# Outline ELEXON Plan_kc

Schedule from MS Project, 2022-10-31 to 2027-12-23, status date 2024-08-23, A marks actual dates.

## Calendars

- Standard: Mon-Fri 08:00-12:00, 13:00-17:00; Sat-Sun off.

## Resources

| Resource |
| --- |
| PMO |
| SI |
| PPC |
| Lead Workstream |
| CPT |
| PP |
| SI Design |
| SI Design |
| SI Design |
| Design |
| SI DevOps |
| SI Test |
| PSG |
| DAG |
| TMAG |
| CCAG |
| Code drafters (SRO Design Team |
| Code Bodies) |
| CCAG PM |
| Programme Participants |
| Code drafters |
| CDWG |
| SRO Design Team |
| Code Bodies |
| Ofgem |
| Elexon resources TBC |
| LDP Programme Manager |
| SRO Client Programme Director |
| IPA |
| LDP |
| SRO |
| )) |
| ? |
| TBC |
| OOC |
| MHHSP |
| Adrian Page |
| Amy Clayton |
| Anand Kaveripatna |
| Berlinda Kugara |
| Cesar Lopes |
| Charlie Blanks |
| Chetan Ubale |
| Daniel Callender |
| Daniel Gee |
| David Hollinshead |
| Dean Bailey |
| Dominic Mooney |
| Elayaraja Jeyaraman |
| Georgi Rabotov |
| Giles Clayden |
| Helen Richardson |
| Ishti Bhatti |
| Jafer Shah |
| Jason Brogden |
| John Edmonds Bell |
| John Wiggins |
| Karthikeyan Ganesan |
| Kasimali Hajiyani |
| Kate Goodman |
| Keegan Moodley |
| Keith Clark |
| Keith Lawlor |
| kevin Davis |
| Kishore Konduru |
| Kyle Abraham |
| Mahjabeen Newaz |
| Martin Freeman |
| Matt Hall |
| Matthew Breen |
| Michael Inije |
| Michael Walton |
| Ming Li |
| Nathalia Revlien |
| Nick Sewell |
| Nigel Hunt |
| Oskar Cahill |
| Paul Pettitt |
| Rakhee Shah |
| Rebecca Farooq |
| Renu Rathor |
| Robert Short |
| Robert Topley |
| Saadia Sajjad |
| Sean Tuffy |
| Shaid Hussain |
| Sharmeen Shaikh |
| Simon Berry |
| Steve Bradford |
| Steve Weston |
| Taaran Suri |
| Waseem Mohammed |
| Zak Hussain |
| berli |
| SI Migration |
| v |
| Andrew Margan |
| Lee Cox |
| DIP SP |
| DIPS SP |
| DIPSP |
| Ian Smith |
| N/A |
| SIT Component Integration Testing 2 Preparation Complete (incl. approval of SI SIT Component Integration Test Readiness Report) |
| Nich |
| Nicola Farley |
| Warren Fulton |
| Richard Puddephatt |
| Matthew Bray |
| Programme |
| LDSOs |
| Ben Wickins |
| paul |
| LDSO |
| Simon chidwick |
| Stuart Scott |
| MHHS Programme |
| Claire Silk |
| Laura Kennedy |
| Rowan B |
| FD |
| MB |
| AM |
| Roger Robar |
| Laura Kennedy. |

## Schedule

| ID | WBS | Task | Type | Duration | Start | Finish | Complete | Remaining | Baseline start | Baseline finish | Baseline duration | Baseline 1 start | Baseline 1 finish | Total slack | Constraint | Baseline cost | Responsible | Involved | Update Version | MHHS Resource Name | Sched Status | RAG | Task Status | Text3 |
| --- | --- | --- | --- | --- | --- | --- | --- | --- | --- | --- | --- | --- | --- | --- | --- | --- | --- | --- | --- | --- | --- | --- | --- | --- |
| 1 | 1 | **PROGRAMME PLAN.** |  | 1344d? | 2022-10-31 A | 2027-12-23 | 51% | 654.22d? | 2022-10-31 | 2027-12-23 | 1195d |  |  | 0d |  | -0 | N/A | N/A | 5.0 | N/A |  |  |  |  |
| 2 | 1.1 | MHHS Programme Start | milestone | 0d | 2022-10-31 A | 2022-10-31 A | 100% |  | 2022-10-31 | 2022-10-31 | 0d |  |  |  |  |  | N/A | N/A | 5.7 | N/A | Complete | COMPLETE |  |  |
| 3 | 1.2 | **PROGRAMME MANAGEMENT** |  | 1089d | 2022-10-31 A | 2026-12-31 | 44% | 609.27d | 2022-10-31 | 2026-12-31 | 1089d | 2022-10-31 | 2026-12-31 | 255d |  |  | N/A | N/A | 5.0 | N/A |  |  |  |  |
| 4 | 1.2.1 | **Programme Management** |  | 1089d | 2022-10-31 A | 2026-12-31 | 43% | 616d | 2022-10-31 | 2026-12-31 | 1089d | 2022-10-31 | 2026-12-31 | 255d |  |  | N/A | N/A | 5.0 | N/A |  |  | M10 |  |
| 5 | 1.2.1.1 | Sprint-based prioritisation planning and execution |  | 1089d | 2022-10-31 A | 2026-12-31 | 43% | 616d | 2022-10-31 | 2026-12-31 | 1089d | 2022-10-31 | 2026-12-31 | 255d | finish no earlier than 2026-12-31 |  | PMO | CPT | 5.0 | N/A | Green | GREEN |  |  |
| 6 | 1.2.1.2 | Programme governance secretariat |  | 1089d | 2022-10-31 A | 2026-12-31 | 43% | 616d | 2022-10-31 | 2026-12-31 | 1089d | 2022-10-31 | 2026-12-31 | 255d |  |  | PMO | CPT | 5.0 | N/A | Green | GREEN |  |  |
| 7 | 1.2.1.3 | RAID management and reporting |  | 1089d | 2022-10-31 A | 2026-12-31 | 43% | 616d | 2022-10-31 | 2026-12-31 | 1089d | 2022-10-31 | 2026-12-31 | 255d |  |  | PMO | CPT | 5.0 | N/A | Green | GREEN |  |  |
| 8 | 1.2.1.4 | Tracking against Programme outcomes and KPIs |  | 1089d | 2022-10-31 A | 2026-12-31 | 43% | 616d | 2022-10-31 | 2026-12-31 | 1089d | 2022-10-31 | 2026-12-31 | 255d |  |  | PMO | CPT | 5.0 | N/A | Green | GREEN |  |  |
| 9 | 1.2.1.5 | Change control and reporting |  | 1089d | 2022-10-31 A | 2026-12-31 | 43% | 616d | 2022-10-31 | 2026-12-31 | 1089d | 2022-10-31 | 2026-12-31 | 255d |  |  | PMO | CPT | 5.0 | N/A | Green | GREEN |  |  |
| 10 | 1.2.1.6 | Ongoing identification of lessons learned relating to the PMO and implementation of improvements |  | 1089d | 2022-10-31 A | 2026-12-31 | 43% | 616d | 2022-10-31 | 2026-12-31 | 1089d | 2022-10-31 | 2026-12-31 | 255d |  |  | PMO | CPT | 5.0 | N/A | Green | GREEN |  |  |
| 11 | 1.2.2 | **Programme Internal Assurance Reviews** |  | 1089d | 2022-10-31 A | 2026-12-31 | 43% | 616d | 2022-10-31 | 2026-12-31 | 1089d | 2022-10-31 | 2026-12-31 | 255d |  |  | N/A | N/A | 5.0 | N/A |  |  | M9 | D18A - Quarterly Assurance Report |
| 12 | 1.2.2.1 | Programme Internal Assurance Reviews |  | 1089d | 2022-10-31 A | 2026-12-31 | 43% | 616d | 2022-10-31 | 2026-12-31 | 1089d | 2022-10-31 | 2026-12-31 | 255d |  |  | CPT | PMO | 5.0 | N/A | Green | GREEN |  | D18A - Quarterly Assurance Report |
| 13 | 1.2.3 | **Engagement with PPs** |  | 1089d | 2022-10-31 A | 2026-12-31 | 43% | 615.89d | 2022-10-31 | 2026-12-31 | 1089d | 2022-10-31 | 2026-12-31 | 255d |  |  | N/A | N/A | 5.0 | N/A |  |  | M5,M6 |  |
| 14 | 1.2.3.1 | Ongoing PP liaison activities |  | 1089d | 2022-10-31 A | 2026-12-31 | 43% | 616d | 2022-10-31 | 2026-12-31 | 1089d | 2022-10-31 | 2026-12-31 | 255d |  |  | PPC | CPT | 5.0 | N/A | Green | GREEN |  |  |
| 15 | 1.2.3.2 | Milestone and Control Point objective setting |  | 1089d | 2022-10-31 A | 2026-12-31 | 43% | 616d | 2022-10-31 | 2026-12-31 | 1089d | 2022-10-31 | 2026-12-31 | 255d |  |  | PPC | CPT | 5.0 | N/A | Green | GREEN |  |  |
| 16 | 1.2.3.3 | Reporting |  | 1089d | 2022-10-31 A | 2026-12-31 | 43% | 616d | 2022-10-31 | 2026-12-31 | 1089d | 2022-10-31 | 2026-12-31 | 255d |  |  | PPC |  | 5.0 | N/A | Green | GREEN |  |  |
| 17 | 1.2.3.4 | **PP Engagement Events** |  | 1089d | 2022-10-31 A | 2026-12-31 | 43% | 616d | 2022-10-31 | 2026-12-31 | 1089d | 2022-10-31 | 2026-12-31 | 255d |  |  | N/A | N/A | 5.0 | N/A |  |  |  |  |
| 18 | 1.2.3.4.1 | Bilateral meetings |  | 1089d | 2022-10-31 A | 2026-12-31 | 43% | 616d | 2022-10-31 | 2026-12-31 | 1089d | 2022-10-31 | 2026-12-31 | 255d |  |  | PPC | CPT | 5.0 | N/A | Green | GREEN |  |  |
| 19 | 1.2.3.4.2 | Monthly webinars |  | 1089d | 2022-10-31 A | 2026-12-31 | 43% | 616d | 2022-10-31 | 2026-12-31 | 1089d | 2022-10-31 | 2026-12-31 | 255d |  |  | PPC | CPT | 5.0 | N/A | Green | GREEN |  |  |
| 20 | 1.2.3.4.3 | Open days |  | 1089d | 2022-10-31 A | 2026-12-31 | 43% | 616d | 2022-10-31 | 2026-12-31 | 1089d | 2022-10-31 | 2026-12-31 | 255d |  |  | PPC | CPT | 5.0 | N/A | Green | GREEN |  |  |
| 21 | 1.2.3.5 | **PP Communications** |  | 1088d | 2022-10-31 A | 2026-12-30 | 43% | 615d | 2022-10-31 | 2026-12-30 | 1088d | 2022-10-31 | 2026-12-30 | 256d |  |  | N/A | N/A | 5.0 | N/A |  |  |  |  |
| 22 | 1.2.3.5.1 | The Clock updates (weekly) |  | 1088d | 2022-10-31 A | 2026-12-30 | 43% | 615d | 2022-10-31 | 2026-12-30 | 1088d | 2022-10-31 | 2026-12-30 | 256d |  |  | PPC |  | 5.0 | N/A | Green | GREEN |  |  |
| 23 | 1.2.3.5.2 | Maintain and update content on public-facing Portal (and ongoing feedback reviews to identify and implement Portal improvements) |  | 1088d | 2022-10-31 A | 2026-12-30 | 43% | 615d | 2022-10-31 | 2026-12-30 | 1088d | 2022-10-31 | 2026-12-30 | 256d |  |  | PPC |  | 5.0 | N/A | Green | GREEN |  |  |
| 24 | 1.2.4 | **Code Change Support / Other Programme Alignment** |  | 1089d | 2022-10-31 A | 2026-12-31 | 43% | 616d | 2022-10-31 | 2026-12-31 | 1089d | 2022-10-31 | 2026-12-31 | 255d |  |  | N/A | N/A | 5.0 | N/A |  |  | M6 | D17 - Code Change Report & Recommendations |
| 25 | 1.2.4.1 | Support DCC/BEIS on SEC change |  | 1089d | 2022-10-31 A | 2026-12-31 | 43% | 616d | 2022-10-31 | 2026-12-31 | 1089d | 2022-10-31 | 2026-12-31 | 255d |  |  | CPT |  | 5.0 | N/A | Green | GREEN |  |  |
| 26 | 1.2.4.2 | Support on Smart Meters Act changes |  | 1089d | 2022-10-31 A | 2026-12-31 | 43% | 616d | 2022-10-31 | 2026-12-31 | 1089d | 2022-10-31 | 2026-12-31 | 255d |  |  | CPT |  | 5.0 | N/A | Green | GREEN |  |  |
| 27 | 1.2.4.3 | Support DCC/RECCo on CSS change |  | 1089d | 2022-10-31 A | 2026-12-31 | 43% | 616d | 2022-10-31 | 2026-12-31 | 1089d | 2022-10-31 | 2026-12-31 | 255d |  |  | CPT |  | 5.0 | N/A | Green | GREEN |  |  |
| 28 | 1.2.4.4 | Support Elexon on BSC change |  | 1089d | 2022-10-31 A | 2026-12-31 | 43% | 616d | 2022-10-31 | 2026-12-31 | 1089d | 2022-10-31 | 2026-12-31 | 255d |  |  | CPT |  | 5.0 | N/A | Green | GREEN |  |  |
| 29 | 1.2.4.5 | Support code change inside & outside CCIAG |  | 1089d | 2022-10-31 A | 2026-12-31 | 43% | 616d | 2022-10-31 | 2026-12-31 | 1089d | 2022-10-31 | 2026-12-31 | 255d |  |  | CPT |  | 5.0 | N/A | Green | GREEN |  |  |
| 30 | 1.2.4.6 | Support code change inside & outside CCAG |  | 1089d | 2022-10-31 A | 2026-12-31 | 43% | 616d | 2022-10-31 | 2026-12-31 | 1089d | 2022-10-31 | 2026-12-31 | 255d |  |  | CPT |  | 5.0 | N/A | Green | GREEN |  |  |

| ID | WBS | Task | Type | Duration | Start | Finish | Predecessors | Complete | Remaining | Baseline start | Baseline finish | Baseline duration | Baseline 1 start | Baseline 1 finish | Total slack | Constraint | Baseline cost | Responsible | Involved | Task Status | Update Version | MHHS Resource Name | Sched Status | RAG | Text3 | MHHS Programme Phase | Artefact ID | Milestone ID | Text29 | Tier |
| --- | --- | --- | --- | --- | --- | --- | --- | --- | --- | --- | --- | --- | --- | --- | --- | --- | --- | --- | --- | --- | --- | --- | --- | --- | --- | --- | --- | --- | --- | --- |
| 31 | 1.2.5 | **Programme Replan Baseline** |  | 163d | 2022-10-31 A | 2023-06-14 A |  | 100% |  | 2022-10-31 | 2023-06-14 | 163d | 2022-10-31 | 2023-06-14 |  |  |  | N/A | N/A | M5+ | 5.0 | N/A |  |  |  |  |  |  |  |  |
| 32 | 1.2.5.1 | Round 3 consultation preparation |  | 32d | 2022-10-31 A | 2022-12-13 A |  | 100% |  | 2022-10-31 | 2022-12-13 | 32d | 2022-10-31 | 2022-12-13 |  |  |  | PMO | CPT |  | 5.0 | N/A | Complete | COMPLETE |  |  |  |  |  |  |
| 33 | 1.2.5.2 | PSG decision to launch Round 3 consultation | milestone | 0d | 2022-12-07 A | 2022-12-07 A | 32FS-5d | 100% |  | 2022-12-07 | 2022-12-07 | 0d | 2022-12-07 | 2022-12-07 |  |  |  | PMO | PPC |  | 5.0 | N/A | Complete | COMPLETE |  |  |  |  |  |  |
| 34 | 1.2.5.3 | Round 3 consultation (incl. walkthroughs and Q&A) |  | 35d | 2022-12-14 A | 2023-01-31 A | 33FS+5d | 100% |  | 2022-12-14 | 2023-01-31 | 35d | 2022-12-14 | 2023-01-31 |  |  |  | PP | PMO, PPC,IPA |  | 5.0 | N/A | Complete | COMPLETE |  |  |  |  |  |  |
| 35 | 1.2.5.4 | Review and uplift of foundational testing documents to align with replan approach |  | 92d | 2022-12-14 A | 2023-04-20 A | 34SS | 100% |  | 2022-12-14 | 2023-04-20 | 92d | 2022-12-14 | 2023-04-20 |  |  |  | SI Test | CPT |  | 5.0 | N/A | Complete | COMPLETE |  |  |  |  |  |  |
| 36 | 1.2.5.5 | Round 3 consultation responses analysis (incl. identification of SIT volunteers) |  | 10d | 2023-02-01 A | 2023-02-14 A | 34 | 100% |  | 2023-02-01 | 2023-02-14 | 10d | 2023-02-01 | 2023-02-14 |  |  |  | PMO | CPT |  | 5.0 | N/A | Complete | COMPLETE |  |  |  |  |  |  |
| 37 | 1.2.5.6 | Replan re-drafting and supporting artefact updates (incl. engagement with Ofgem) |  | 26d | 2023-02-15 A | 2023-03-22 A | 36 | 100% |  | 2023-02-15 | 2023-03-22 | 26d | 2023-02-15 | 2023-03-22 |  |  |  | PMO | CPT,IPA,Ofgem |  | 5.0 | N/A | Complete | COMPLETE |  |  |  |  |  |  |
| 38 | 1.2.5.7 | Draft Replan Change Request |  | 31d | 2023-02-15 A | 2023-03-29 A | 36 | 100% |  | 2023-02-15 | 2023-03-29 | 31d | 2023-02-15 | 2023-03-29 |  |  |  | PMO | CPT |  | 5.0 | N/A | Complete | COMPLETE |  |  |  |  |  |  |
| 39 | 1.2.5.8 | PSG decision to issue CR for industry impact assessment | milestone | 0d | 2023-04-05 A | 2023-04-05 A | 38FS+5d | 100% |  | 2023-04-05 | 2023-04-05 | 0d | 2023-04-05 | 2023-04-05 |  |  |  | PMO | CPT |  | 5.0 | N/A | Complete | COMPLETE |  |  |  |  |  |  |
| 40 | 1.2.5.9 | Industry impact assessment |  | 10d | 2023-04-06 A | 2023-04-19 A | 39 | 100% |  | 2023-04-06 | 2023-04-19 | 10d | 2023-04-06 | 2023-04-19 |  |  |  | PP | PMO,PPC |  | 5.0 | N/A | Complete | COMPLETE |  |  |  |  |  |  |
| 41 | 1.2.5.10 | Replan playbacks (to assist PPs in impact assessment) |  | 5d | 2023-04-11 A | 2023-04-17 A | 40SS+3d | 100% |  | 2023-04-11 | 2023-04-17 | 5d | 2023-04-11 | 2023-04-17 |  |  |  | CPT | PPC,PP |  | 5.0 | N/A | Complete | COMPLETE |  |  |  |  |  |  |
| 42 | 1.2.5.11 | Industry impact assessment responses analysis |  | 5d | 2023-04-20 A | 2023-04-26 A | 40 | 100% |  | 2023-04-20 | 2023-04-26 | 5d | 2023-04-20 | 2023-04-26 |  |  |  | PMO | CPT |  | 5.0 | N/A | Complete | COMPLETE |  |  |  |  |  |  |
| 43 | 1.2.5.12 | Extraordinary PSG decision to agree baseline recommendation | milestone | 0d | 2023-05-03 A | 2023-05-03 A | 42FS+5d | 100% |  | 2023-05-03 | 2023-05-03 | 0d | 2023-05-03 | 2023-05-03 |  |  |  | CPT | PMO,PP |  | 5.0 | N/A | Complete | COMPLETE |  |  |  |  |  |  |
| 44 | 1.2.5.13 | Programme Replan playbacks and drop-in sessions |  | 5d | 2023-06-08 A | 2023-06-14 A |  | 100% |  | 2023-06-08 | 2023-06-14 | 5d | 2023-06-08 | 2023-06-14 |  |  |  | PMO | PPC, PP |  | 5.0 | N/A | Complete | COMPLETE |  |  |  |  |  |  |
| 45 | 1.3 | **DESIGN, BUILD & TEST (PIT)** |  | 1221d? | 2022-10-31 A | 2027-07-05 |  | 78% | 273.62d? | 2022-10-31 | 2027-07-05 | 1101d | 2022-10-31 | 2027-01-18 | 123d |  | -0 | N/A | N/A |  |  | N/A |  |  | 1 May 2022 - 31 Jul 2023 | Design, Build & Test (PIT) |  |  |  |  |
| 46 | 1.3.1 | **Design Baseline & Enduring PP Support** |  | 1101d | 2022-10-31 A | 2027-01-18 |  | 71% | 319.69d | 2022-10-31 | 2027-01-18 | 1101d | 2022-10-31 | 2027-01-18 | 243d |  | -0 | N/A | N/A |  | 5.0 | N/A |  |  |  | Design, Build & Test (PIT) |  |  |  |  |
| 47 | 1.3.1.1 | Physical design baselined (M5) | milestone | 0d | 2022-10-31 A | 2022-10-31 A |  | 100% |  | 2022-10-31 | 2022-10-31 | 0d | 2022-10-31 | 2022-10-31 |  |  |  | SRO Design | SI Design,PP,IPA |  | 5.0 | Paul Pettitt | Complete | COMPLETE |  | Design, Build & Test (PIT) | MHHS-ART001 | T1-DB-1000 | PSG | T1 |
| 48 | 1.3.1.2 | **M5 Design Work-Off Plan Implementation & Approval** |  | 79d | 2022-10-31 A | 2023-02-16 A |  | 100% |  | 2022-10-31 | 2023-02-16 | 79d | 2022-10-31 | 2023-02-16 |  |  |  | N/A | N/A |  | 5.0 | N/A |  |  |  | Design, Build & Test (PIT) |  |  |  |  |
| 49 | 1.3.1.2.1 | Implementation of M5 design Work-Off Plan |  | 74d | 2022-10-31 A | 2023-02-09 A | 47 | 100% |  | 2022-10-31 | 2023-02-09 | 74d | 2022-10-31 | 2023-02-09 |  |  |  | SI Design | PP |  | 5.0 | Paul Pettitt | Complete | COMPLETE |  | Design, Build & Test (PIT) |  |  |  |  |
| 50 | 1.3.1.2.2 | M5 design Work-Off Plan completion approved | milestone | 0d | 2023-02-16 A | 2023-02-16 A | 49FS+5d | 100% |  | 2023-02-16 | 2023-02-16 | 0d | 2023-02-16 | 2023-02-16 |  |  |  | SI Design | PP |  | 5.0 | Paul Pettitt | Complete | COMPLETE |  | Design, Build & Test (PIT) |  | T3-DB-0014 | DAG | T3 |
| 51 | 1.3.1.3 | **Enduring PP Design Support** |  | 1089d | 2022-10-31 A | 2026-12-31 A |  | 100% |  | 2022-10-31 | 2026-12-31 | 1089d | 2022-10-31 | 2026-12-31 |  |  |  | N/A | N/A |  | 5.0 | N/A |  |  |  | Design, Build & Test (PIT) |  |  |  |  |
| 52 | 1.3.1.3.1 | Design playbacks and drop-in sessions |  | 45d | 2022-10-31 A | 2022-12-30 A | 47 | 100% |  | 2022-10-31 | 2022-12-30 | 45d | 2022-10-31 | 2022-12-30 |  |  |  | SI Design | PMO,PPC, SRO Design |  | 5.0 | Paul Pettitt | Complete | COMPLETE |  | Design, Build & Test (PIT) |  |  |  |  |
| 53 | 1.3.1.3.2 | Support participants on E2E MHHS Design |  | 1089d | 2022-10-31 A | 2026-12-31 A | 47 | 100% |  | 2022-10-31 | 2026-12-31 | 1089d | 2022-10-31 | 2026-12-31 |  |  |  | SI Design | PP |  | 5.0 | Paul Pettitt | Complete | COMPLETE |  | Design, Build & Test (PIT) |  |  |  |  |
| 54 | 1.3.1.3.3 | DIP Onboarding Support |  | 70d | 2022-11-14 A | 2023-02-17 A |  | 100% |  | 2022-11-14 | 2023-02-17 | 70d | 2022-11-14 | 2023-02-17 |  | must start on 2022-11-14 |  | SI Design | SRO Design |  | 5.0 | Paul Pettitt | Complete | COMPLETE |  | Design, Build & Test (PIT) |  |  |  |  |
| 55 | 1.3.1.3.4 | iServer Launch | milestone | 0d | 2023-02-16 A | 2023-02-16 A | 50 | 100% |  | 2023-02-16 | 2023-02-16 | 0d | 2023-02-16 | 2023-02-16 |  |  |  | SI Design | PP |  | 5.0 | Paul Pettitt | Complete | COMPLETE |  | Design, Build & Test (PIT) |  |  |  |  |

| ID | WBS | Task | Type | Duration | Start | Finish | Predecessors | Complete | Remaining | Baseline start | Baseline finish | Baseline duration | Baseline 1 start | Baseline 1 finish | Total slack | Constraint | Baseline cost | Responsible | Involved | Update Version | MHHS Resource Name | MHHS Programme Phase | Sched Status | RAG | Milestone ID | Text29 | Tier |
| --- | --- | --- | --- | --- | --- | --- | --- | --- | --- | --- | --- | --- | --- | --- | --- | --- | --- | --- | --- | --- | --- | --- | --- | --- | --- | --- | --- |
| 56 | 1.3.1.4 | **Establish Design Change Management Processes** |  | 1101d | 2022-10-31 A | 2027-01-18 |  | 36% | 706.22d | 2022-10-31 | 2027-01-18 | 1101d | 2022-10-31 | 2027-01-18 | 243d |  |  | N/A | N/A | 5.0 | N/A | Design, Build & Test (PIT) |  |  |  |  |  |
| 57 | 1.3.1.4.1 | Internal review of internal change management processes |  | 35d | 2022-10-31 A | 2022-12-16 A |  | 100% |  | 2022-10-31 | 2022-12-16 | 35d | 2022-10-31 | 2022-12-16 |  |  |  | SRO | SI Design | 5.0 | Paul Pettitt | Design, Build & Test (PIT) | Complete | COMPLETE |  |  |  |
| 58 | 1.3.1.4.2 | SRO approval of internal change management processes | milestone | 0d | 2022-12-16 A | 2022-12-16 A | 57FF | 100% |  | 2022-12-16 | 2022-12-16 | 0d | 2022-12-16 | 2022-12-16 |  |  |  | SRO | SI Design | 5.0 | Paul Pettitt | Design, Build & Test (PIT) | Complete | COMPLETE |  |  |  |
| 59 | 1.3.1.4.3 | Change Process Webinar | milestone | 0d | 2023-01-16 A | 2023-01-16 A |  | 100% |  | 2023-01-16 | 2023-01-16 | 0d | 2023-01-16 | 2023-01-16 |  | must start on 2023-01-16 |  | SI Design | PP | 5.0 | Paul Pettitt | Design, Build & Test (PIT) | Complete | COMPLETE |  |  |  |
| 60 | 1.3.1.4.4 | Enduring change management process approved | milestone | 0d | 2023-02-16 A | 2023-02-16 A | 50FF | 100% |  | 2023-02-16 | 2023-02-16 | 0d | 2023-02-16 | 2023-02-16 |  |  |  | SI Design | PP | 5.0 | Paul Pettitt | Design, Build & Test (PIT) | Complete | COMPLETE | T3-DB-0016 | DAG | T3 |
| 61 | 1.3.1.4.5 | Maintain E2E MHHS Design (post-M5 design change management processes operational) |  | 1022d | 2023-02-17 A | 2027-01-18 | 60 | 34% | 678d | 2023-02-17 | 2027-01-18 | 1022d | 2023-02-17 | 2027-01-18 | 243d |  |  | SI Design | PP | 5.0 | Paul Pettitt | Design, Build & Test (PIT) | Green | GREEN |  |  |  |
| 62 | 1.3.1.5 | **Design Authority Mobilisation** |  | 29d | 2022-12-14 A | 2023-01-23 A |  | 100% |  | 2022-12-14 | 2023-01-23 | 29d | 2022-12-14 | 2023-01-23 |  |  |  | N/A | N/A | 5.0 | N/A | Design, Build & Test (PIT) |  |  |  |  |  |
| 63 | 1.3.1.5.1 | Design Authority ToR approved | milestone | 0d | 2022-12-14 A | 2022-12-14 A |  | 100% |  | 2022-12-14 | 2022-12-14 | 0d | 2022-12-14 | 2022-12-14 |  | must start on 2022-12-14 |  | SI Design | PP | 5.0 | Paul Pettitt | Design, Build & Test (PIT) | Complete | COMPLETE | T3-DB-0010 | DAG | T3 |
| 64 | 1.3.1.5.2 | Inaugural Design Authority | milestone | 0d | 2023-01-23 A | 2023-01-23 A | 63FS+29d | 100% |  | 2023-01-23 | 2023-01-23 | 0d | 2023-01-23 | 2023-01-23 |  |  |  | SI Design | PP | 5.0 | Paul Pettitt | Design, Build & Test (PIT) | Complete | COMPLETE |  |  |  |
| 65 | 1.3.1.6 | **Network Operation Services Adaptor Procurement** |  | 0d | 2023-05-23 A | 2023-05-23 A |  | 100% |  | 2023-05-23 | 2023-05-23 | 0d | 2023-02-01 | 2025-03-14 |  |  | -0 | N/A | N/A | 5.0 | N/A | Design, Build & Test (PIT) |  |  |  |  |  |
| 66 | 1.3.1.6.1 | All SIT LDSOs have procured their adapter providers | milestone | 0d | 2023-05-23 A | 2023-05-23 A | 581SS | 100% |  | 2023-05-23 | 2023-05-23 | 0d | 2023-05-23 | 2023-05-23 |  |  |  | SI Design | PP | 5.0 | Paul Pettitt | Design, Build & Test (PIT) | Complete | COMPLETE | T3-DB-0020 | DAG | T3 |
| 67 | 1.3.2 | **PP Mobilisation** |  | 67d | 2022-10-31 A | 2023-01-31 A |  | 100% |  | 2022-10-31 | 2023-01-31 | 67d | 2022-10-31 | 2023-01-31 |  |  |  | N/A | N/A | 5.0 | N/A | Design, Build & Test (PIT) |  |  |  |  |  |
| 68 | 1.3.2.1 | Set up governance |  | 67d | 2022-10-31 A | 2023-01-31 A |  | 100% |  | 2022-10-31 | 2023-01-31 | 67d | 2022-10-31 | 2023-01-31 |  |  |  | PP |  | 5.0 | PP | Design, Build & Test (PIT) | Complete | COMPLETE |  |  |  |
| 69 | 1.3.2.2 | Set up reporting |  | 67d | 2022-10-31 A | 2023-01-31 A |  | 100% |  | 2022-10-31 | 2023-01-31 | 67d | 2022-10-31 | 2023-01-31 |  |  |  | PP |  | 5.0 | PP | Design, Build & Test (PIT) | Complete | COMPLETE |  |  |  |
| 70 | 1.3.2.3 | Obtain funding |  | 67d | 2022-10-31 A | 2023-01-31 A |  | 100% |  | 2022-10-31 | 2023-01-31 | 67d | 2022-10-31 | 2023-01-31 |  |  |  | PP |  | 5.0 | PP | Design, Build & Test (PIT) | Complete | COMPLETE |  |  |  |
| 71 | 1.3.2.4 | Earmark resources |  | 67d | 2022-10-31 A | 2023-01-31 A |  | 100% |  | 2022-10-31 | 2023-01-31 | 67d | 2022-10-31 | 2023-01-31 |  |  |  | PP |  | 5.0 | PP | Design, Build & Test (PIT) | Complete | COMPLETE |  |  |  |
| 72 | 1.3.2.5 | Mobilise initial team |  | 67d | 2022-10-31 A | 2023-01-31 A |  | 100% |  | 2022-10-31 | 2023-01-31 | 67d | 2022-10-31 | 2023-01-31 |  |  |  | PP |  | 5.0 | PP | Design, Build & Test (PIT) | Complete | COMPLETE |  |  |  |
| 73 | 1.3.3 | **PIT Stub Specification and Delivery** |  | 435d | 2022-10-31 A | 2024-06-28 A |  | 100% |  | 2022-10-31 | 2024-06-28 | 430d | 2022-10-31 | 2023-05-31 |  |  | -0 | N/A | N/A | 5.0 | N/A | Design, Build & Test (PIT) |  |  |  |  |  |
| 74 | 1.3.3.1 | **DIP Simulator** |  | 108d | 2022-10-31 A | 2023-03-29 A |  | 100% |  | 2022-10-31 | 2023-03-29 | 108d | 2022-10-31 | 2023-03-29 |  |  |  | N/A | N/A | 5.0 | N/A | Design, Build & Test (PIT) |  |  |  |  |  |
| 75 | 1.3.3.1.1 | Build & Test |  | 95d | 2022-10-31 A | 2023-03-10 A | 47 | 100% |  | 2022-10-31 | 2023-03-10 | 95d | 2022-10-31 | 2023-03-10 |  |  |  | SI DevOps |  | 5.0 | Rebecca Farooq | Design, Build & Test (PIT) | Complete | COMPLETE |  |  |  |
| 76 | 1.3.3.1.2 | UAT |  | 85d | 2022-11-14 A | 2023-03-10 A | 75SS+10d | 100% |  | 2022-11-14 | 2023-03-10 | 85d | 2022-11-14 | 2023-03-10 |  |  |  | SI Test |  | 5.0 | Rebecca Farooq | Design, Build & Test (PIT) | Complete | COMPLETE |  |  |  |
| 77 | 1.3.3.1.3 | Beta test |  | 95d | 2022-10-31 A | 2023-03-10 A | 75SS | 100% |  | 2022-10-31 | 2023-03-10 | 95d | 2022-10-31 | 2023-03-10 |  |  |  | PP | SI Test | 5.0 | Rebecca Farooq | Design, Build & Test (PIT) | Complete | COMPLETE |  |  |  |
| 78 | 1.3.3.1.4 | Prepare for release |  | 18d | 2023-03-06 A | 2023-03-29 A | 77FS-5d | 100% |  | 2023-03-06 | 2023-03-29 | 18d | 2023-03-06 | 2023-03-29 |  |  |  | SI DevOps |  | 5.0 | Rebecca Farooq | Design, Build & Test (PIT) | Complete | COMPLETE |  |  |  |
| 79 | 1.3.3.1.5 | DIP Simulator released | milestone | 0d | 2023-03-29 A | 2023-03-29 A | 78FF | 100% |  | 2023-03-29 | 2023-03-29 | 0d | 2023-03-29 | 2023-03-29 |  | start no earlier than 2023-01-30 |  | SI DevOps |  | 5.0 | Rebecca Farooq | Design, Build & Test (PIT) | Complete | COMPLETE | T3-DB-0018 | SITAG | T3 |

| ID | WBS | Task | Type | Duration | Start | Finish | Predecessors | Complete | Remaining | Baseline start | Baseline finish | Baseline duration | Baseline 1 start | Baseline 1 finish | Total slack | Constraint | Baseline cost | Responsible | Involved | Update Version | MHHS Resource Name | MHHS Programme Phase | Sched Status | RAG | Milestone ID | Text29 | Tier |
| --- | --- | --- | --- | --- | --- | --- | --- | --- | --- | --- | --- | --- | --- | --- | --- | --- | --- | --- | --- | --- | --- | --- | --- | --- | --- | --- | --- |
| 80 | 1.3.3.2 | **DIP Simulator Uplifts** |  | 257d | 2023-07-06 A | 2024-06-28 A |  | 100% |  | 2023-07-06 | 2024-06-28 | 252d |  |  |  |  | -0 | N/A | N/A | 5.1 | N/A | Design, Build & Test (PIT) |  |  |  |  |  |
| 81 | 1.3.3.2.1 | DIP Simulator uplifted to align with design releases - design/build/test |  | 27d | 2023-07-06 A | 2023-08-11 A | 117 | 100% |  | 2023-07-06 | 2023-08-11 | 27d |  |  |  |  |  | SI DevOps |  | 5.1 | Rebecca Farooq | Design, Build & Test (PIT) | Complete | COMPLETE |  |  |  |
| 82 | 1.3.3.2.2 | DIP Simulator uplifted to align with Interim Release 2 | milestone | 0d | 2023-08-11 A | 2023-08-11 A | 81 | 100% |  | 2023-08-11 | 2023-08-11 | 0d |  |  |  |  |  | SI DevOps |  | 5.1 | Rebecca Farooq | Design, Build & Test (PIT) | Complete | COMPLETE | T3-DB-0035 | SITAG | T3 |
| 83 | 1.3.3.2.3 | DIP Simulator uplifted to align with design releases - design/build/test |  | 20d | 2023-10-09 A | 2023-11-03 A | 126FS+2d | 100% |  | 2023-10-09 | 2023-11-03 | 20d |  |  |  |  |  | SI DevOps |  | 5.3 | Rebecca Farooq | Design, Build & Test (PIT) | Complete | COMPLETE |  |  |  |
| 84 | 1.3.3.2.4 | DIP Simulator uplifted to align with Interim Release 5 | milestone | 0d | 2023-11-03 A | 2023-11-03 A | 83 | 100% |  | 2023-11-03 | 2023-11-03 | 0d |  |  |  |  |  | SI DevOps |  | 5.11 | Rebecca Farooq | Design, Build & Test (PIT) | Complete | COMPLETE | T3-DB-0039 | SITAG | T3 |
| 85 | 1.3.3.2.5 | DIP Simulator uplifted to align with design releases - design/build/test |  | 37d | 2024-02-01 A | 2024-03-22 A | 134 | 100% |  | 2024-02-01 | 2024-03-22 | 37d |  |  |  |  |  | SI DevOps | PP,SRO,Testing | 5.14 | Matthew Bray | Design, Build & Test (PIT) | Complete | COMPLETE |  |  |  |
| 86 | 1.3.3.2.6 | DIP Simulator uplifted to align with Interim Release 7 | milestone | 0d | 2024-03-22 A | 2024-03-22 A | 85 | 100% |  | 2024-03-22 | 2024-03-22 | 0d |  |  |  |  |  | SI DevOps | PP,SRO,Testing | 5.14 | Matthew Bray | Design, Build & Test (PIT) | Complete | COMPLETE | T3-DB-0182 | SITAG | T3 |
| 87 | 1.3.3.2.7 | DIP Simulator uplifted to align with design releases - design/build/test |  | 57d | 2024-04-04 A | 2024-06-21 A | 138 | 100% |  | 2024-04-04 | 2024-06-21 | 57d |  |  |  |  |  | SI DevOps | PP,SRO,Testing | 5.14 | Matthew Bray | Design, Build & Test (PIT) | Complete | COMPLETE |  |  |  |
| 88 | 1.3.3.2.8 | DIP Simulator uplifted to align with Interim Release 8 | milestone | 0d | 2024-06-28 A | 2024-06-28 A | 87FS+5d | 100% |  | 2024-06-28 | 2024-06-28 | 0d |  |  |  |  |  | SI DevOps | PP,SRO,Testing | 5.28 | Matthew Bray | Design, Build & Test (PIT) | Complete | COMPLETE | T3-DB-0183 | SITAG | T3 |
| 89 | 1.3.3.3 | **Data Generator** |  | 130d | 2022-12-01 A | 2023-05-31 A |  | 100% |  | 2022-12-01 | 2023-05-31 | 130d | 2022-12-01 | 2023-05-31 |  |  |  | N/A | N/A | 5.0 | N/A | Design, Build & Test (PIT) |  |  |  |  |  |
| 90 | 1.3.3.3.1 | Design | manual | 15d | 2022-12-01 A | 2022-12-21 A |  | 100% |  | 2022-12-01 | 2022-12-21 | 15d | 2022-12-01 | 2022-12-21 |  |  |  | SI DevOps |  | 5.0 | Rebecca Farooq | Design, Build & Test (PIT) | Complete | COMPLETE |  |  |  |
| 91 | 1.3.3.3.2 | Build & Test |  | 50d | 2023-02-16 A | 2023-04-26 A | 90FS+40d | 100% |  | 2023-02-16 | 2023-04-26 | 50d | 2023-02-16 | 2023-04-26 |  |  |  | SI DevOps |  | 5.0 | Rebecca Farooq | Design, Build & Test (PIT) | Complete | COMPLETE |  |  |  |
| 92 | 1.3.3.3.3 | UAT |  | 10d | 2023-04-27 A | 2023-05-10 A | 91 | 100% |  | 2023-04-27 | 2023-05-10 | 10d | 2023-04-27 | 2023-05-10 |  |  |  | SI Test |  | 5.0 | Rebecca Farooq | Design, Build & Test (PIT) | Complete | COMPLETE |  |  |  |
| 93 | 1.3.3.3.4 | Beta test |  | 45d | 2023-03-30 A | 2023-05-31 A | 91FS-20d, 95FF | 100% |  | 2023-03-30 | 2023-05-31 | 45d | 2023-03-30 | 2023-05-31 |  |  |  | PP | SI Test | 5.0 | Rebecca Farooq | Design, Build & Test (PIT) | Complete | COMPLETE |  |  |  |
| 94 | 1.3.3.3.5 | Prepare for release |  | 24d | 2023-04-27 A | 2023-05-30 A | 92SS | 100% |  | 2023-04-27 | 2023-05-30 | 24d | 2023-04-27 | 2023-05-30 |  |  |  | SI DevOps |  | 5.0 | Rebecca Farooq | Design, Build & Test (PIT) | Complete | COMPLETE |  |  |  |
| 95 | 1.3.3.3.6 | Data Generator released | milestone | 0d | 2023-05-31 A | 2023-05-31 A | 94FS+1d | 100% |  | 2023-05-31 | 2023-05-31 | 0d | 2023-05-31 | 2023-05-31 |  |  |  | SI DevOps |  | 5.0 | Rebecca Farooq | Design, Build & Test (PIT) | Complete | COMPLETE | T3-DB-0022 | SITAG | T3 |
| 96 | 1.3.4 | **Design Artefact Releases** |  | 451d | 2023-02-22 A | 2024-11-13 |  | 99% | 0d | 2023-02-22 | 2024-11-13 | 398d | 2023-02-22 | 2023-09-29 | 811d |  | -0 | N/A | N/A | 5.0 | N/A | Design, Build & Test (PIT) |  |  |  |  |  |
| 97 | 1.3.4.1 | **Interim release 1** |  | 79d | 2023-02-22 A | 2023-06-12 A |  | 100% |  | 2023-02-22 | 2023-06-12 | 79d | 2023-02-22 | 2023-06-28 |  |  |  | N/A | N/A | 5.0 | N/A | Design, Build & Test (PIT) |  |  |  |  |  |
| 98 | 1.3.4.1.1 | Prioritise DINs and CR |  | 1d | 2023-02-22 A | 2023-02-22 A |  | 100% |  | 2023-02-22 | 2023-02-22 | 1d | 2023-02-22 | 2023-02-22 |  | must start on 2023-02-22 |  | SI Design |  | 5.0 | Paul Pettitt | Design, Build & Test (PIT) | Complete | COMPLETE |  |  |  |
| 99 | 1.3.4.1.2 | **Industry input session** |  | 7d | 2023-02-23 A | 2023-03-03 A |  | 100% |  | 2023-02-23 | 2023-03-03 | 7d | 2023-02-23 | 2023-03-03 |  |  |  | N/A | N/A | 5.0 | N/A | Design, Build & Test (PIT) |  |  |  |  |  |
| 100 | 1.3.4.1.2.1 | Raise a CR covering prioritized assessment cluster |  | 1d | 2023-02-23 A | 2023-02-23 A | 98 | 100% |  | 2023-02-23 | 2023-02-23 | 1d | 2023-02-23 | 2023-02-23 |  |  |  | SI Design |  | 5.0 | Paul Pettitt | Design, Build & Test (PIT) | Complete | COMPLETE |  |  |  |
| 101 | 1.3.4.1.2.2 | Organize Industry Input session to go through significant items to reach consensus |  | 1d | 2023-02-23 A | 2023-02-23 A | 100SS | 100% |  | 2023-02-23 | 2023-02-23 | 1d | 2023-02-23 | 2023-02-23 |  |  |  | SI Design | PP | 5.0 | Paul Pettitt,Berlinda Kugara | Design, Build & Test (PIT) | Complete | COMPLETE |  |  |  |
| 102 | 1.3.4.1.2.3 | Conduct Meeting |  | 1d | 2023-03-03 A | 2023-03-03 A | 101FS+5d | 100% |  | 2023-03-03 | 2023-03-03 | 1d | 2023-03-03 | 2023-03-03 |  |  |  | SI Design | PP | 5.0 | Paul Pettitt,Berlinda Kugara | Design, Build & Test (PIT) | Complete | COMPLETE |  |  |  |
| 103 | 1.3.4.1.3 | Update baselined artefacts |  | 10d | 2023-03-24 A | 2023-04-06 A |  | 100% |  | 2023-03-24 | 2023-04-06 | 10d | 2023-03-24 | 2023-04-06 |  |  |  | SI Design |  | 5.0 | Paul Pettitt | Design, Build & Test (PIT) | Complete | COMPLETE |  |  |  |

Notes:
- 84: Amber as S&E couldn't view design docs, & assess scope changes. Required workload likely more than 2 sprints (original estimate). Additional MS work & CIT testing support has stretched capacity further. Delivery could be delayed. / Action: 26/7/23 - forecast changed from 15/12/23 - 3/11/23 - Changed from Interim Release 6 to 5. Updated in milestone register
- 86: 11/12- Add new milestone to reflect confirmation of Interim Release Delivery dates. 20/12 - Approved at TMAG on 20/12
- 88: 20/6: Date missed because a decision was taken and agreed with SRO to bundle IR8 and IR8.1, meaning a later combined release date of 28/6. No PP impact as PIT for SIT Cycle 3 will be baselined against IR8.1

| ID | WBS | Task | Type | Duration | Start | Finish | Predecessors | Complete | Baseline start | Baseline finish | Baseline duration | Baseline 1 start | Baseline 1 finish | Constraint | Baseline cost | Responsible | Involved | Update Version | MHHS Resource Name | MHHS Programme Phase | Sched Status | RAG | Milestone ID | Text29 | Tier | Action |
| --- | --- | --- | --- | --- | --- | --- | --- | --- | --- | --- | --- | --- | --- | --- | --- | --- | --- | --- | --- | --- | --- | --- | --- | --- | --- | --- |
| 104 | 1.3.4.1.4 | **Participant review and impact assess changes** |  | 18d | 2023-04-14 A | 2023-05-09 A |  | 100% | 2023-04-14 | 2023-05-09 | 18d | 2023-04-14 | 2023-05-09 |  |  | N/A | N/A | 5.0 | N/A | Design, Build & Test (PIT) |  |  |  |  |  |  |
| 105 | 1.3.4.1.4.1 | Issue Redline Version of documents |  | 1d | 2023-04-14 A | 2023-04-14 A | 103FS+5d | 100% | 2023-04-14 | 2023-04-14 | 1d | 2023-04-14 | 2023-04-14 |  |  | SI Design |  | 5.0 | Paul Pettitt | Design, Build & Test (PIT) | Complete | COMPLETE |  |  |  |  |
| 106 | 1.3.4.1.4.2 | Participants provide review comments to common log |  | 17d | 2023-04-17 A | 2023-05-09 A | 105 | 100% | 2023-04-17 | 2023-05-09 | 17d | 2023-04-17 | 2023-05-09 |  |  | PP |  | 5.0 | Paul Pettitt | Design, Build & Test (PIT) | Complete | COMPLETE |  |  |  |  |
| 107 | 1.3.4.1.5 | **Assurance review** |  | 19d | 2023-05-10 A | 2023-06-05 A |  | 100% | 2023-05-10 | 2023-06-05 | 19d | 2023-05-10 | 2023-06-05 |  |  | N/A | N/A | 5.0 | N/A | Design, Build & Test (PIT) |  |  |  |  |  |  |
| 108 | 1.3.4.1.5.1 | SI Design Review and Respond to Comments |  | 5d | 2023-05-10 A | 2023-05-16 A | 106 | 100% | 2023-05-10 | 2023-05-16 | 5d | 2023-05-10 | 2023-05-16 |  |  | SI Design |  | 5.0 | Paul Pettitt | Design, Build & Test (PIT) | Complete | COMPLETE |  |  |  |  |
| 109 | 1.3.4.1.5.2 | Prep for Assurance Review Meeting |  | 7d | 2023-05-17 A | 2023-05-25 A | 108 | 100% | 2023-05-17 | 2023-05-25 | 7d | 2023-05-17 | 2023-05-25 |  |  | SI Design |  | 5.0 | Paul Pettitt | Design, Build & Test (PIT) | Complete | COMPLETE |  |  |  |  |
| 110 | 1.3.4.1.5.3 | Conduct Assurance Review Meeting |  | 1d | 2023-05-26 A | 2023-05-26 A | 109 | 100% | 2023-05-26 | 2023-05-26 | 1d | 2023-05-26 | 2023-05-26 |  |  | SI Design |  | 5.0 | Paul Pettitt | Design, Build & Test (PIT) | Complete | COMPLETE |  |  |  |  |
| 111 | 1.3.4.1.5.4 | Update Artefacts following Assurance Review |  | 6d | 2023-05-29 A | 2023-06-05 A | 110 | 100% | 2023-05-29 | 2023-06-05 | 6d | 2023-05-29 | 2023-06-05 |  |  | SI Design |  | 5.0 | Paul Pettitt | Design, Build & Test (PIT) | Complete | COMPLETE |  |  |  |  |
| 112 | 1.3.4.1.6 | PSG Approval of interim release plan |  | 1d | 2023-06-08 A | 2023-06-08 A |  | 100% | 2023-06-08 | 2023-06-08 | 1d |  |  | must start on 2023-06-08 |  | PP | SI Design | 5.1 | Paul Pettitt | Design, Build & Test (PIT) | Complete | COMPLETE |  |  |  |  |
| 113 | 1.3.4.1.7 | Publish updated baselined artefacts | milestone | 0d | 2023-06-06 A | 2023-06-12 A | 111 | 100% | 2023-06-06 | 2023-06-12 | 5d | 2023-06-15 | 2023-06-21 |  |  | SI Design |  | 5.0 | Paul Pettitt | Design, Build & Test (PIT) | Complete | COMPLETE |  |  |  |  |
| 114 | 1.3.4.1.8 | Interim release 1 Go live | milestone | 0d | 2023-06-12 A | 2023-06-12 A | 113 | 100% | 2023-06-12 | 2023-06-12 | 0d | 2023-06-28 | 2023-06-28 |  |  | SI Design |  | 5.0 | Paul Pettitt | Design, Build & Test (PIT) | Complete | COMPLETE | T3-DB-0095 | DAG | T3 |  |
| 115 | 1.3.4.2 | **Interim release 2** |  | 27d | 2023-05-30 A | 2023-07-05 A |  | 100% | 2023-05-30 | 2023-07-05 | 27d | 2023-05-24 | 2023-07-28 |  |  | N/A | N/A | 5.0 | N/A | Design, Build & Test (PIT) |  |  |  |  |  |  |
| 116 | 1.3.4.2.1 | Update baselined artefacts |  | 27d | 2023-05-30 A | 2023-07-05 A |  | 100% | 2023-05-30 | 2023-07-05 | 27d |  |  | must start on 2023-05-30 |  | SI Design | PP | 5.1 | Paul Pettitt | Design, Build & Test (PIT) | Complete | COMPLETE |  |  |  |  |
| 117 | 1.3.4.2.2 | Interim release 2 Go live | milestone | 0d | 2023-07-05 A | 2023-07-05 A | 116 | 100% | 2023-07-05 | 2023-07-05 | 0d | 2023-07-28 | 2023-07-28 |  |  | SI Design |  | 5.0 | Paul Pettitt | Design, Build & Test (PIT) | Complete | COMPLETE | T3-DB-0096 | DAG | T3 |  |
| 118 | 1.3.4.3 | **Interim release 3** |  | 35d | 2023-06-15 A | 2023-08-02 A |  | 100% | 2023-06-15 | 2023-08-02 | 35d | 2023-06-29 | 2023-09-29 |  |  | N/A | N/A | 5.0 | N/A | Design, Build & Test (PIT) |  |  |  |  |  |  |
| 119 | 1.3.4.3.1 | Update baselined artefacts |  | 35d | 2023-06-15 A | 2023-08-02 A |  | 100% | 2023-06-15 | 2023-08-02 | 35d |  |  | must start on 2023-06-15 |  | SI Design | PP | 5.1 | Paul Pettitt | Design, Build & Test (PIT) | Complete | COMPLETE |  |  |  |  |
| 120 | 1.3.4.3.2 | Interim release 3 Go live | milestone | 0d | 2023-08-02 A | 2023-08-02 A | 119 | 100% | 2023-08-02 | 2023-08-02 | 0d | 2023-09-29 | 2023-09-29 |  |  | SI Design |  | 5.0 | Paul Pettitt | Design, Build & Test (PIT) | Complete | COMPLETE | T3-DB-0097 | DAG | T3 |  |
| 121 | 1.3.4.4 | **Interim release 4** |  | 36d | 2023-07-12 A | 2023-08-30 A |  | 100% | 2023-07-12 | 2023-08-30 | 36d |  |  |  |  | N/A | N/A | 5.1 | N/A | Design, Build & Test (PIT) |  |  |  |  |  |  |
| 122 | 1.3.4.4.1 | Update baselined artefacts |  | 36d | 2023-07-12 A | 2023-08-30 A |  | 100% | 2023-07-12 | 2023-08-30 | 36d |  |  | must start on 2023-07-12 |  | SI Design | PP | 5.1 | Paul Pettitt | Design, Build & Test (PIT) | Complete | COMPLETE |  |  |  |  |
| 123 | 1.3.4.4.2 | Interim release 4 Go live | milestone | 0d | 2023-08-30 A | 2023-08-30 A | 122 | 100% | 2023-08-30 | 2023-08-30 | 0d |  |  |  |  | SI Design |  | 5.1 | Paul Pettitt | Design, Build & Test (PIT) | Complete | COMPLETE | T3-DB-0081 | DAG | T3 |  |
| 124 | 1.3.4.5 | **Interim release 5** |  | 147d | 2023-08-17 A | 2024-03-08 A |  | 100% | 2023-08-17 | 2024-03-08 | 147d |  |  |  | -0 | N/A | N/A | 5.1 | N/A | Design, Build & Test (PIT) |  |  |  |  |  |  |
| 125 | 1.3.4.5.1 | Update baselined artefacts |  | 35d | 2023-08-17 A | 2023-10-04 A |  | 100% | 2023-08-17 | 2023-10-04 | 35d |  |  | must start on 2023-08-17 |  | SI Design | PP | 5.1 | Paul Pettitt | Design, Build & Test (PIT) | Complete | COMPLETE |  |  |  |  |
| 126 | 1.3.4.5.2 | Interim release 5 Go live | milestone | 0d | 2023-10-04 A | 2023-10-04 A | 125 | 100% | 2023-10-04 | 2023-10-04 | 0d |  |  |  |  | SI Design |  | 5.1 | Paul Pettitt | Design, Build & Test (PIT) | Complete | COMPLETE | T3-DB-0083 | DAG | T3 | 11/8 - successor is SIT functional (starts in march) |
| 127 | 1.3.4.5.3 | Interim Release 5 Deployed to SIT |  | 10d | 2024-02-26 A | 2024-03-08 A | 126FS+102d | 100% | 2024-02-26 | 2024-03-08 | 10d |  |  |  |  | SI Testing | PP | 5.16 |  |  | Complete | COMPLETE |  |  |  |  |

| ID | WBS | Task | Type | Duration | Start | Finish | Predecessors | Complete | Remaining | Baseline start | Baseline finish | Baseline duration | Baseline 1 start | Baseline 1 finish | Total slack | Free slack | Constraint | Baseline cost | Responsible | Involved | Update Version | MHHS Resource Name | MHHS Programme Phase | Sched Status | RAG | Milestone ID | Text29 | Tier | Action | Task Status |
| --- | --- | --- | --- | --- | --- | --- | --- | --- | --- | --- | --- | --- | --- | --- | --- | --- | --- | --- | --- | --- | --- | --- | --- | --- | --- | --- | --- | --- | --- | --- |
| 128 | 1.3.4.6 | **Interim release 6** |  | 192d | 2023-09-14 A | 2024-06-07 A |  | 100% |  | 2023-09-14 | 2024-06-07 | 192d |  |  |  |  |  | -0 | N/A | N/A | 5.1 | N/A | Design, Build & Test (PIT) |  |  |  |  |  |  |  |
| 129 | 1.3.4.6.1 | Update baselined artefacts |  | 35d | 2023-09-14 A | 2023-11-01 A |  | 100% |  | 2023-09-14 | 2023-11-01 | 32d |  |  |  |  | must start on 2023-09-14 |  | SI Design | PP | 5.1 | Paul Pettitt | Design, Build & Test (PIT) | Complete | COMPLETE |  |  |  |  |  |
| 130 | 1.3.4.6.2 | Interim release 6 Go live | milestone | 0d | 2023-11-01 A | 2023-11-01 A | 129 | 100% |  | 2023-11-01 | 2023-11-01 | 0d |  |  |  |  |  |  | SI Design |  | 5.11 | Paul Pettitt | Design, Build & Test (PIT) | Complete | COMPLETE | T3-DB-0085 | DAG | T3 |  |  |
| 131 | 1.3.4.6.3 | Interim Release 6 Deployed to SIT |  | 10d | 2024-05-27 A | 2024-06-07 A | 130FS+147d | 100% |  | 2024-05-27 | 2024-06-07 | 10d |  |  |  |  |  |  | SI Testing | PP | 5.16 |  |  | Complete | COMPLETE |  |  |  |  |  |
| 132 | 1.3.4.7 | **Interim release 7** |  | 168d | 2023-10-18 A | 2024-06-07 A |  | 100% |  | 2023-10-18 | 2024-06-07 | 168d |  |  |  |  |  | -0 | N/A | N/A | 5.5 | N/A | Design, Build & Test (PIT) |  |  |  |  |  |  |  |
| 133 | 1.3.4.7.1 | Update baselined artefacts |  | 76d | 2023-10-18 A | 2024-01-31 A |  | 100% |  | 2023-10-18 | 2024-01-31 | 76d |  |  |  |  | start no earlier than 2023-10-18 |  | SI Design | PP | 5.5 | Paul Pettitt | Design, Build & Test (PIT) | Complete | COMPLETE |  |  |  |  |  |
| 134 | 1.3.4.7.2 | Interim release 7 Go live | milestone | 0d | 2024-01-31 A | 2024-01-31 A | 133 | 100% |  | 2024-01-31 | 2024-01-31 | 0d |  |  |  |  |  |  | SI Design | PP | 5.14 | Paul Pettitt | Design, Build & Test (PIT) | Complete | COMPLETE | T3-DB-0098 | DAG | T3 | 4/8 - add as t3 milestones. Awaiting approval at TMAG |  |
| 135 | 1.3.4.7.3 | Interim Release 7 Deployed to SIT |  | 10d | 2024-05-27 A | 2024-06-07 A | 134FS+82d | 100% |  | 2024-05-27 | 2024-06-07 | 10d |  |  |  |  |  |  | SI Testing | PP | 5.16 |  |  | Complete | COMPLETE |  |  |  |  |  |
| 136 | 1.3.4.8 | **Interim release 8** |  | 196d | 2024-02-14 A | 2024-11-13 |  | 99% | 0d | 2024-02-14 | 2024-11-13 | 143d |  |  | 811d |  |  | -0 | N/A | N/A | 5.5 | N/A | Design, Build & Test (PIT) |  |  |  |  |  |  |  |
| 137 | 1.3.4.8.1 | Update baselined artefacts |  | 36d | 2024-02-14 A | 2024-04-03 A |  | 100% |  | 2024-02-14 | 2024-04-03 | 36d |  |  |  |  | start no earlier than 2024-02-14 |  | SI Design | PP | 5.5 | Paul Pettitt | Design, Build & Test (PIT) | Complete | COMPLETE |  |  |  |  |  |
| 138 | 1.3.4.8.2 | Interim release 8 Go live | milestone | 0d | 2024-04-03 A | 2024-04-03 A | 137 | 100% |  | 2024-04-03 | 2024-04-03 | 0d |  |  |  |  | start no earlier than 2024-01-10 |  | SI Design | PP | 5.14 | Paul Pettitt | Design, Build & Test (PIT) | Complete | COMPLETE | T3-DB-0099 | DAG | T3 | 4/8 - add as t3 milestones. Awaiting approval at TMAG |  |
| 139 | 1.3.4.8.3 | **Interim Release 8.3 - Maintenance Window** |  | 11d | 2024-10-07 | 2024-10-21 |  |  |  | 2024-10-07 | 2024-10-21 |  |  |  | 16d |  |  |  | Design |  | 6.0 |  |  | Overdue Start | green |  |  |  |  | -686.67 |
| 140 | 1.3.4.8.3.1 | Interim Release 8.3 'effective from date' to SIT A | milestone | 0d | 2024-10-21 | 2024-10-21 | 138FS+143d |  |  | 2024-10-21 | 2024-10-21 | 10d |  |  | 5d | 0d |  |  | SI Testing | PP | 5.16 | Roger Robar |  | Green | GREEN |  |  |  |  | 3.71 |
| 141 | 1.3.4.8.3.2 | Interim Release 8.3 'effective from date' to SIT B | milestone | 0d | 2024-10-07 | 2024-10-07 | 140SS-11d |  |  | 2024-10-07 | 2024-10-07 |  |  |  | 38d | 0d |  |  | Design |  | 5.16 |  |  | Green | GREEN |  |  |  |  | -10.67 |
| 142 | 1.3.4.8.4 | **Interim Release 8.4** |  | 36d | 2024-09-25 A | 2024-11-13 |  | 99% | 0d | 2024-09-25 | 2024-11-13 |  |  |  | 811d |  |  |  | Design |  | 6.1 |  |  | Overdue Start | GREEN |  |  |  |  | -694.67 |
| 143 | 1.3.4.8.4.1 | Update baselined artefacts |  | 8d | 2024-09-25 A | 2024-10-04 A |  | 100% |  | 2024-09-25 | 2024-10-04 |  |  |  |  |  | start no earlier than 2024-09-25 |  | Design |  | 6.1 |  |  | Complete | COMPLETE |  |  |  |  |  |
| 144 | 1.3.4.8.4.2 | Interim release 8.4 Published | milestone | 0d | 2024-10-16 | 2024-10-16 | 143FS+8d |  |  | 2024-10-16 | 2024-10-16 |  |  |  | 811d | 0d | start no earlier than 2024-10-09 |  | Design |  | 6.1 |  |  | Green | GREEN |  |  |  |  | -1.29 |
| 145 | 1.3.4.8.4.3 | Interim Release 8.4 Deployed to SIT by Participants | milestone | 0d | 2024-11-13 | 2024-11-13 | 144FS+20d |  |  | 2024-11-13 | 2024-11-13 |  |  |  | 811d |  |  |  | Design |  | 6.1 |  |  | Green | GREEN |  |  |  |  | 26.71 |
| 146 | 1.3.5 | **Queries Support / Knowledgebase & Tool Roll-Out (Systems)** |  | 325d | 2023-01-03 A | 2024-04-01 A |  | 100% |  | 2023-01-03 | 2024-04-01 | 325d | 2023-01-03 | 2024-04-01 |  |  |  |  | N/A | N/A | 5.0 | N/A | Design, Build & Test (PIT) |  |  |  |  |  |  |  |
| 147 | 1.3.5.1 | **Query Management** |  | 325d | 2023-01-03 A | 2024-04-01 A |  | 100% |  | 2023-01-03 | 2024-04-01 | 325d | 2023-01-03 | 2024-04-01 |  |  |  |  | N/A | N/A | 5.0 | N/A | Design, Build & Test (PIT) |  |  |  |  |  |  |  |
| 148 | 1.3.5.1.1 | Respond to Participant Queries |  | 325d | 2023-01-03 A | 2024-04-01 A |  | 100% |  | 2023-01-03 | 2024-04-01 | 325d | 2023-01-03 | 2024-04-01 |  |  | must start on 2023-01-03 |  | SI Design | PP | 5.0 | Paul Pettitt | Design, Build & Test (PIT) | Complete | COMPLETE |  |  |  | 11/8 - runs out to end of the programme |  |
| 149 | 1.3.5.1.2 | Respond to Programme Queries |  | 325d | 2023-01-03 A | 2024-04-01 A | 148SS | 100% |  | 2023-01-03 | 2024-04-01 | 325d | 2023-01-03 | 2024-04-01 |  |  |  |  | SI Design | PP | 5.0 | Paul Pettitt | Design, Build & Test (PIT) | Complete | COMPLETE |  |  |  | 11/8 - runs out to end of the programme |  |
| 150 | 1.3.5.2 | **Query Support tooling (FreshDesk)** |  | 23d | 2023-06-01 A | 2023-07-03 A |  | 100% |  | 2023-06-01 | 2023-07-03 | 23d | 2023-06-01 | 2023-07-03 |  |  |  |  | N/A | N/A | 5.0 | N/A | Design, Build & Test (PIT) |  |  |  |  |  |  |  |
| 151 | 1.3.5.2.1 | Migrate to Standalone Freshdesk |  | 10d | 2023-06-01 A | 2023-06-14 A |  | 100% |  | 2023-06-01 | 2023-06-14 | 10d | 2023-06-01 | 2023-06-14 |  |  | must start on 2023-06-01 |  | SI Design |  | 5.0 | Paul Pettitt | Design, Build & Test (PIT) | Complete | COMPLETE |  |  |  |  |  |
| 152 | 1.3.5.2.2 | Develop reporting dashboard |  | 5d | 2023-06-15 A | 2023-06-21 A | 151 | 100% |  | 2023-06-15 | 2023-06-21 | 5d | 2023-06-15 | 2023-06-21 |  |  |  |  | SI Design |  | 5.0 | Paul Pettitt | Design, Build & Test (PIT) | Complete | COMPLETE |  |  |  |  |  |
| 153 | 1.3.5.2.3 | Issue to SRO for Review |  | 5d | 2023-06-22 A | 2023-06-28 A | 152 | 100% |  | 2023-06-22 | 2023-06-28 | 5d | 2023-06-22 | 2023-06-28 |  |  |  |  | SI Design |  | 5.0 | Paul Pettitt | Design, Build & Test (PIT) | Complete | COMPLETE |  |  |  |  |  |
| 154 | 1.3.5.2.4 | Update following review |  | 2d | 2023-06-29 A | 2023-06-30 A | 153 | 100% |  | 2023-06-29 | 2023-06-30 | 2d | 2023-06-29 | 2023-06-30 |  |  |  |  | SI Design |  | 5.0 | Paul Pettitt | Design, Build & Test (PIT) | Complete | COMPLETE |  |  |  |  |  |
| 155 | 1.3.5.2.5 | Sign off |  | 1d | 2023-07-03 A | 2023-07-03 A | 154 | 100% |  | 2023-07-03 | 2023-07-03 | 1d | 2023-07-03 | 2023-07-03 |  |  |  |  | SI Design |  | 5.0 | Paul Pettitt | Design, Build & Test (PIT) | Complete | COMPLETE |  |  |  |  |  |

Notes:
- 133: 4/8 - Added in as per PPs advice
- 134: 27/11- Red because forecast date has changed to align with Testing Release Management. Discussed with no objections at FTIG on 23/11. To be taken to Dec DAG for noting
- 137: 4/8 - Added in as per PPs advice
- 138: 27/11- Amber because forecast date has changed to align with Testing Release Management. Discussed with no objections at FTIG on 23/11. To be taken to Dec DAG for noting

| ID | WBS | Task | Duration | Start | Finish | Predecessors | Complete | Remaining | Baseline start | Baseline finish | Baseline duration | Baseline 1 start | Baseline 1 finish | Total slack | Free slack | Constraint | Baseline cost | Responsible | Involved | Update Version | MHHS Resource Name | MHHS Programme Phase | Sched Status | RAG | Task Status |
| --- | --- | --- | --- | --- | --- | --- | --- | --- | --- | --- | --- | --- | --- | --- | --- | --- | --- | --- | --- | --- | --- | --- | --- | --- | --- |
| 156 | 1.3.5.3 | **KnowledgeBase Development** | 72d | 2023-06-01 A | 2023-09-08 A |  | 100% |  | 2023-06-01 | 2023-09-08 | 72d | 2023-06-01 | 2023-09-08 |  |  |  |  | N/A | N/A | 5.0 | N/A | Design, Build & Test (PIT) |  |  |  |
| 157 | 1.3.5.3.1 | Define Scope of KB | 1d | 2023-06-01 A | 2023-06-01 A | 151SS | 100% |  | 2023-06-01 | 2023-06-01 | 1d | 2023-06-01 | 2023-06-01 |  |  |  |  | SI Design |  | 5.0 | Paul Pettitt | Design, Build & Test (PIT) | Complete | COMPLETE |  |
| 158 | 1.3.5.3.2 | Capture Existing KB artefacts | 20d | 2023-06-02 A | 2023-06-29 A | 157 | 100% |  | 2023-06-02 | 2023-06-29 | 20d | 2023-06-02 | 2023-06-29 |  |  |  |  | SI Design |  | 5.0 | Paul Pettitt | Design, Build & Test (PIT) | Complete | COMPLETE |  |
| 159 | 1.3.5.3.3 | Tag artefacts | 5d | 2023-06-30 A | 2023-07-06 A | 158 | 100% |  | 2023-06-30 | 2023-07-06 | 5d | 2023-06-30 | 2023-07-06 |  |  |  |  | SI Design |  | 5.0 | Paul Pettitt | Design, Build & Test (PIT) | Complete | COMPLETE |  |
| 160 | 1.3.5.3.4 | Develop Participant Interfaces | 20d | 2023-07-07 A | 2023-08-03 A | 159 | 100% |  | 2023-07-07 | 2023-08-03 | 20d | 2023-07-07 | 2023-08-03 |  |  |  |  | SI Design |  | 5.0 | Paul Pettitt | Design, Build & Test (PIT) | Complete | COMPLETE |  |
| 161 | 1.3.5.3.5 | Promote to Collaboration Portal | 21d | 2023-08-04 A | 2023-09-01 A | 160 | 100% |  | 2023-08-04 | 2023-09-01 | 21d | 2023-08-04 | 2023-09-01 |  |  |  |  | SI Design |  | 5.0 | Paul Pettitt | Design, Build & Test (PIT) | Complete | COMPLETE |  |
| 162 | 1.3.5.3.6 | Link into FreshDesk | 5d | 2023-09-04 A | 2023-09-08 A | 161 | 100% |  | 2023-09-04 | 2023-09-08 | 5d | 2023-09-04 | 2023-09-08 |  |  |  |  | SI Design |  | 5.0 | Paul Pettitt | Design, Build & Test (PIT) | Complete | COMPLETE |  |
| 163 | 1.3.6 | **PP Design, Build & Test (DBT)** | 1221d? | 2022-10-31 A | 2027-07-05 |  | 82% | 216.25d? | 2022-10-31 | 2027-07-05 | 495d | 2022-10-31 | 2026-02-16 | 123d |  |  | -0 | N/A | N/A | 5.0 | N/A | Design, Build & Test (PIT) |  |  |  |
| 164 | 1.3.6.1 | **PP Impact Assessment, Planning & Procurement** | 110d | 2022-10-31 A | 2023-03-31 A |  | 100% |  | 2022-10-31 | 2023-03-31 | 110d | 2022-10-31 | 2023-03-31 |  |  |  |  | N/A | N/A | 5.0 | N/A | Design, Build & Test (PIT) |  |  |  |
| 165 | 1.3.6.1.1 | **PP Impact Assessment** | 67d | 2022-10-31 A | 2023-01-31 A |  | 100% |  | 2022-10-31 | 2023-01-31 | 67d | 2022-10-31 | 2023-01-31 |  |  |  |  | N/A | N/A | 5.0 | N/A | Design, Build & Test (PIT) |  |  |  |
| 166 | 1.3.6.1.1.1 | Develop heatmap for impact of MHHS | 67d | 2022-10-31 A | 2023-01-31 A | 47 | 100% |  | 2022-10-31 | 2023-01-31 | 67d | 2022-10-31 | 2023-01-31 |  |  |  |  | PP |  | 5.0 | PP | Design, Build & Test (PIT) | Complete | COMPLETE |  |
| 167 | 1.3.6.1.1.2 | Develop detailed impact assessment | 67d | 2022-10-31 A | 2023-01-31 A | 47 | 100% |  | 2022-10-31 | 2023-01-31 | 67d | 2022-10-31 | 2023-01-31 |  |  |  |  | PP |  | 5.0 | PP | Design, Build & Test (PIT) | Complete | COMPLETE |  |
| 168 | 1.3.6.1.2 | **PP Planning** | 67d | 2022-10-31 A | 2023-01-31 A |  | 100% |  | 2022-10-31 | 2023-01-31 | 67d | 2022-10-31 | 2023-01-31 |  |  |  |  | N/A | N/A | 5.0 | N/A | Design, Build & Test (PIT) |  |  |  |
| 169 | 1.3.6.1.2.1 | Develop detailed short-term plan | 23d | 2022-10-31 A | 2022-11-30 A | 47 | 100% |  | 2022-10-31 | 2022-11-30 | 23d | 2022-10-31 | 2022-11-30 |  |  |  |  | PP |  | 5.0 | PP | Design, Build & Test (PIT) | Complete | COMPLETE |  |
| 170 | 1.3.6.1.2.2 | Develop overall project plan for implementation | 67d | 2022-10-31 A | 2023-01-31 A | 47 | 100% |  | 2022-10-31 | 2023-01-31 | 67d | 2022-10-31 | 2023-01-31 |  |  |  |  | PP |  | 5.0 | PP | Design, Build & Test (PIT) | Complete | COMPLETE |  |
| 171 | 1.3.6.1.2.3 | Develop procurement plan | 67d | 2022-10-31 A | 2023-01-31 A | 47 | 100% |  | 2022-10-31 | 2023-01-31 | 67d | 2022-10-31 | 2023-01-31 |  |  |  |  | PP |  | 5.0 | PP | Design, Build & Test (PIT) | Complete | COMPLETE |  |
| 172 | 1.3.6.1.3 | **PP Software/Service Procurement** | 110d | 2022-10-31 A | 2023-03-31 A |  | 100% |  | 2022-10-31 | 2023-03-31 | 110d | 2022-10-31 | 2023-03-31 |  |  |  |  | N/A | N/A | 5.0 | N/A | Design, Build & Test (PIT) |  |  |  |
| 173 | 1.3.6.1.3.1 | Run tender process | 67d | 2022-10-31 A | 2023-01-31 A | 47 | 100% |  | 2022-10-31 | 2023-01-31 | 67d | 2022-10-31 | 2023-01-31 |  |  |  |  | PP |  | 5.0 | PP | Design, Build & Test (PIT) | Complete | COMPLETE |  |
| 174 | 1.3.6.1.3.2 | Select provider & sign commercials | 43d | 2023-02-01 A | 2023-03-31 A | 173 | 100% |  | 2023-02-01 | 2023-03-31 | 43d | 2023-02-01 | 2023-03-31 |  |  |  |  | PP |  | 5.0 | PP | Design, Build & Test (PIT) | Complete | COMPLETE |  |
| 175 | 1.3.6.2 | **Design Handover** | 741d? | 2024-09-02 A | 2027-07-05 |  | 2% | 722.52d? | 2024-09-02 | 2027-07-05 |  |  |  | 123d |  |  |  | Design |  | 6.1 | Paul Pettit |  | Overdue Start | RED | -694.67 |
| 176 | 1.3.6.2.1 | **Creation of the Configuration Management Database** | 14d | 2024-09-02 | 2024-09-19 |  |  |  | 2024-09-02 | 2024-09-19 |  |  |  | 850d |  |  |  | Design |  | 6.1 | Paul Pettit |  | Overdue Start | RED | -701.67 |
| 177 | 1.3.6.2.1.1 | Identify all baselined design artefacts | 9d | 2024-09-02 | 2024-09-12 |  |  |  | 2024-09-02 | 2024-09-12 |  |  |  | 850d | 0d | start no earlier than 2024-09-02 |  | Design |  | 6.1 | Paul Pettit |  | Green | GREEN | -45.67 |
| 178 | 1.3.6.2.1.2 | Create CMBD | 5d | 2024-09-13 | 2024-09-19 | 177 |  |  | 2024-09-13 | 2024-09-19 |  |  |  | 850d |  |  |  | Design |  | 6.1 | Paul Pettit |  | Green | GREEN | -34.67 |
| 179 | 1.3.6.2.2 | **Knowledge Transfer** | 41d? | 2024-09-02 | 2024-10-28 |  |  |  | 2024-09-02 | 2024-10-28 |  |  |  | 823d |  |  |  | Design |  | 6.1 | Paul Pettit |  | Overdue Start | RED | -701.67 |
| 180 | 1.3.6.2.2.1 | Elexon to document knowledge transfer requirements | 9d? | 2024-09-02 | 2024-09-12 |  |  |  | 2024-09-02 | 2024-09-12 |  |  |  | 834d | 0d | start no earlier than 2024-09-02 |  | Design |  | 6.1 | Paul Pettit |  | Green | RED | -45.67 |
| 181 | 1.3.6.2.2.2 | Review Requirements | 5d | 2024-09-13 | 2024-09-19 | 180 |  |  | 2024-09-13 | 2024-09-19 |  |  |  | 834d | 0d |  |  | Design |  | 6.1 | Paul Pettit |  | Green | RED | -34.67 |
| 182 | 1.3.6.2.2.3 | Agree Success Criteria | 10d | 2024-09-20 | 2024-10-03 | 181 |  |  | 2024-09-20 | 2024-10-03 |  |  |  | 834d | 0d |  |  | Design |  | 6.1 | Paul Pettit |  | Green | RED | -27.67 |
| 183 | 1.3.6.2.2.4 | Identify Key personel with Elexon | 3d | 2024-10-04 | 2024-10-08 | 182 |  |  | 2024-10-04 | 2024-10-08 |  |  |  | 834d | 0d |  |  | Design |  | 6.1 | Paul Pettit |  | Green | RED | -13.67 |
| 184 | 1.3.6.2.2.5 | Draft Agenda for initial meeting | 1d? | 2024-10-09 | 2024-10-09 | 183 |  |  | 2024-10-09 | 2024-10-09 |  |  |  | 834d | 0d |  |  | Design |  | 6.1 | Paul Pettit |  | Green | RED | -8.67 |
| 185 | 1.3.6.2.2.6 | Define cadence for handover sessions | 2d | 2024-10-10 | 2024-10-11 | 184 |  |  | 2024-10-10 | 2024-10-11 |  |  |  | 834d |  |  |  | Design |  | 6.1 | Paul Pettit |  | Green | RED | -7.67 |
| 186 | 1.3.6.2.2.7 | Share Design Information | 20d | 2024-09-02 | 2024-09-27 |  |  |  | 2024-09-02 | 2024-09-27 |  |  |  | 844d |  | start no earlier than 2024-09-02 |  | Design |  | 6.1 | Paul Pettit |  | Green | RED | -45.67 |
| 187 | 1.3.6.2.2.8 | Conduct Initial Handover Session | 20d? | 2024-10-01 | 2024-10-28 |  |  |  | 2024-10-01 | 2024-10-28 |  |  |  | 823d |  | start no earlier than 2024-10-01 |  | Design |  | 6.1 | Paul Pettit |  | Green | RED | -16.67 |

| ID | WBS | Task | Duration | Start | Finish | Predecessors | Complete | Remaining | Baseline start | Baseline finish | Baseline duration | Baseline 1 start | Baseline 1 finish | Total slack | Free slack | Constraint | Baseline cost | Responsible | Task Status | Update Version | Sched Status | MHHS Resource Name | RAG | Involved | MHHS Programme Phase |
| --- | --- | --- | --- | --- | --- | --- | --- | --- | --- | --- | --- | --- | --- | --- | --- | --- | --- | --- | --- | --- | --- | --- | --- | --- | --- |
| 188 | 1.3.6.2.3 | **Triage Sessions** | 131d? | 2024-10-01 | 2025-04-01 |  |  |  | 2024-10-01 | 2025-04-01 |  |  |  | 712d |  |  |  | Design | -701.67 | 6.1 | Overdue Start | Paul Pettit | RED |  |  |
| 189 | 1.3.6.2.3.1 | Design Triage Sessions | 131d? | 2024-10-01 | 2025-04-01 |  |  |  | 2024-10-01 | 2025-04-01 |  |  |  | 712d |  | start no earlier than 2024-10-01 |  | Design | -16.67 | 6.1 | Green | Paul Pettit | RED |  |  |
| 190 | 1.3.6.2.3.2 | Test Triage Sessions | 131d? | 2024-10-01 | 2025-04-01 |  |  |  | 2024-10-01 | 2025-04-01 |  |  |  | 712d |  | finish no earlier than 2025-04-01 |  | Design | -16.67 | 6.1 | Green | Paul Pettit | RED |  |  |
| 191 | 1.3.6.2.4 | **Knowledge Base** | 9d | 2024-09-02 A | 2024-09-12 A |  | 100% |  | 2024-09-02 | 2024-09-12 |  |  |  |  |  |  |  | Design | -701.67 | 6.1 | Overdue Start | Paul Pettit | COMPLETE |  |  |
| 192 | 1.3.6.2.4.1 | Document Knowledge base update process | 4d | 2024-09-02 A | 2024-09-05 A |  | 100% |  | 2024-09-02 | 2024-09-05 |  |  |  |  |  | start no earlier than 2024-09-02 |  | Design |  | 6.1 | Complete | Paul Pettit | COMPLETE |  |  |
| 193 | 1.3.6.2.4.2 | Document Design updates to Collaboration Base | 5d | 2024-09-06 A | 2024-09-12 A |  | 100% |  | 2024-09-06 | 2024-09-12 |  |  |  |  |  | start no earlier than 2024-09-06 |  | Design |  | 6.1 | Complete | Paul Pettit | COMPLETE |  |  |
| 194 | 1.3.6.2.5 | **FreshDesk** | 30d? | 2025-02-03 | 2025-03-14 |  |  |  | 2025-02-03 | 2025-03-14 |  |  |  | 724d |  |  |  | Design | -701.67 | 6.1 | Overdue Start | Paul Pettit | GREEN |  |  |
| 195 | 1.3.6.2.5.1 | Agree Indicative Handover of FreshDesk Calls to Service Now | 4d | 2025-02-03 | 2025-02-06 |  |  |  | 2025-02-03 | 2025-02-06 |  |  |  | 750d |  | start no earlier than 2025-02-03 |  | Design | 108.33 | 6.1 | Green | Paul Pettit | GREEN |  |  |
| 196 | 1.3.6.2.5.2 | Prepare Comms to Industry | 10d | 2025-02-07 | 2025-02-20 |  |  |  | 2025-02-07 | 2025-02-20 |  |  |  | 740d |  | start no earlier than 2025-02-07 |  | Design | 112.33 | 6.1 | Green | Paul Pettit | GREEN |  |  |
| 197 | 1.3.6.2.5.3 | Issue Comms to Industry | 1d? | 2025-02-21 | 2025-02-21 |  |  |  | 2025-02-21 | 2025-02-21 |  |  |  | 739d |  | start no earlier than 2025-02-21 |  | Design | 126.33 | 6.1 | Green | Paul Pettit | GREEN |  |  |
| 198 | 1.3.6.2.5.4 | Redirect Design Mailbox to Service Now | 1d? | 2025-03-03 | 2025-03-03 |  |  |  | 2025-03-03 | 2025-03-03 |  |  |  | 733d |  | start no earlier than 2025-03-03 |  | Design | 136.33 | 6.1 | Green | Paul Pettit | GREEN |  |  |
| 199 | 1.3.6.2.5.5 | Archive Freshdesk calls | 5d | 2025-03-03 | 2025-03-07 |  |  |  | 2025-03-03 | 2025-03-07 |  |  |  | 729d |  | start no earlier than 2025-03-03 |  | Design | 136.33 | 6.1 | Green | Paul Pettit | GREEN |  |  |
| 200 | 1.3.6.2.5.6 | Decommission FreshDesk | 5d | 2025-03-10 | 2025-03-14 |  |  |  | 2025-03-10 | 2025-03-14 |  |  |  | 724d |  | start no earlier than 2025-03-10 |  | Design | 143.33 | 6.1 | Green | Paul Pettit | GREEN |  |  |
| 201 | 1.3.6.2.6 | **Iserver** | 611d? | 2025-03-03 A | 2027-07-05 |  | 5% | 580.45d? | 2025-03-03 | 2027-07-05 |  |  |  |  |  |  |  | Design | -701.67 | 6.1 | Overdue Start | Paul Pettit | GREEN |  |  |
| 202 | 1.3.6.2.6.1 | Gather Licensing information | 1d? | 2025-03-03 A | 2025-03-03 A |  | 100% |  | 2025-03-03 | 2025-03-03 |  |  |  |  |  | start no earlier than 2025-03-03 |  | Design |  | 6.1 | Complete | Paul Pettit | COMPLETE |  |  |
| 203 | 1.3.6.2.6.2 | Clear down old information | 5d | 2025-03-03 | 2025-03-07 |  |  |  | 2025-03-03 | 2025-03-07 |  |  |  | 715d | 0d |  |  | Design | 136.33 | 6.1 | Green | Paul Pettit | GREEN |  |  |
| 204 | 1.3.6.2.6.3 | Clear down accounts | 2d | 2025-03-10 | 2025-03-11 | 203 |  |  | 2025-03-10 | 2025-03-11 |  |  |  | 715d | 14d | start no earlier than 2025-03-10 |  | Design | 143.33 | 6.1 | Green | Paul Pettit | GREEN |  |  |
| 205 | 1.3.6.2.6.4 | Identify Collaboration Base Design Dependencies on iServer | 2d | 2025-04-01 | 2025-04-02 | 204 |  |  | 2025-04-01 | 2025-04-02 |  |  |  | 701d | 0d | start no earlier than 2025-04-01 |  | Design | 165.33 | 6.1 | Green | Paul Pettit | GREEN |  |  |
| 206 | 1.3.6.2.6.5 | Remove Design dependencies | 5d | 2025-04-03 | 2025-04-09 | 205 |  |  | 2025-04-03 | 2025-04-09 |  |  |  | 701d | 0d | start no earlier than 2025-04-03 |  | Design | 167.33 | 6.1 | Green | Paul Pettit | GREEN |  |  |
| 207 | 1.3.6.2.6.6 | Close down iServer | 5d | 2025-04-10 | 2025-04-16 | 206 |  |  | 2025-04-10 | 2025-04-16 |  |  |  | 701d |  | start no earlier than 2025-04-10 |  | Design | 174.33 | 6.1 | Green | Paul Pettit | GREEN |  |  |
| 208 | 1.3.6.3 | **Central Systems DBT** | 325d | 2022-10-31 A | 2024-01-26 A |  | 100% |  | 2022-10-31 | 2024-01-26 | 345d | 2022-10-31 | 2024-05-13 |  |  |  | -0 | N/A | -316.67 | 5.0 |  | N/A |  | N/A | Design, Build & Test (PIT) |
| 209 | 1.3.6.3.1 | **Elexon Central Systems DBT CIT (Entering at Interval 1)** | 248d | 2022-10-31 A | 2023-10-11 A |  | 100% |  | 2022-10-31 | 2023-10-11 | 249d | 2022-10-31 | 2023-09-29 |  |  |  | -0 | N/A |  | 5.0 |  | N/A |  | N/A | Design, Build & Test (PIT) |
| 210 | 1.3.6.3.1.1 | **Design and Build** | 235d | 2022-10-31 A | 2023-09-22 A |  | 100% |  | 2022-10-31 | 2023-09-22 | 240d | 2022-10-31 | 2023-09-29 |  |  |  |  | N/A | -259.67 | 5.0 |  | N/A |  | N/A | Design, Build & Test (PIT) |
| 211 | 1.3.6.3.1.1.1 | Helix Design and Build | 235d | 2022-10-31 A | 2023-09-22 A | 2 | 100% |  | 2022-10-31 | 2023-09-22 | 240d | 2022-10-31 | 2023-09-29 |  |  |  |  | PP |  | 5.0 | Complete |  | COMPLETE | SI Test | Design, Build & Test (PIT) |

| ID | WBS | Task | Type | Duration | Start | Finish | Predecessors | Complete | Baseline start | Baseline finish | Baseline duration | Baseline 1 start | Baseline 1 finish | Constraint | Baseline cost | Responsible | Involved | Update Version | MHHS Resource Name | MHHS Programme Phase | Sched Status | RAG | Milestone ID | Text29 | Tier | Artefact ID |
| --- | --- | --- | --- | --- | --- | --- | --- | --- | --- | --- | --- | --- | --- | --- | --- | --- | --- | --- | --- | --- | --- | --- | --- | --- | --- | --- |
| 212 | 1.3.6.3.1.2 | **Test Approach & Plan** |  | 235d | 2022-10-31 A | 2023-09-22 A |  | 100% | 2022-10-31 | 2023-09-22 | 235d | 2022-10-31 | 2023-07-21 |  | -0 | N/A | N/A | 5.0 | N/A | Design, Build & Test (PIT) |  |  |  |  |  |  |
| 213 | 1.3.6.3.1.2.1 | Develop Test Approach & Plan |  | 180d | 2022-10-31 A | 2023-07-07 A |  | 100% | 2022-10-31 | 2023-07-07 | 180d | 2022-10-31 | 2023-07-07 |  |  | PP | SI Test | 5.0 |  | Design, Build & Test (PIT) | Complete | COMPLETE |  |  |  |  |
| 214 | 1.3.6.3.1.2.2 | Elexon Central Systems Test Approach & Plan (PIT) submitted to Programme for assurance | milestone | 0d | 2023-07-13 A | 2023-07-13 A | 213FF+4d | 100% | 2023-07-13 | 2023-07-13 | 0d | 2023-07-07 | 2023-07-07 |  |  | PP | SI Test | 5.0 |  | Design, Build & Test (PIT) | Complete | COMPLETE | T3-DB-0029 | SITAG | T3 |  |
| 215 | 1.3.6.3.1.2.3 | Elexon Central Systems Test Approach & Plan (PIT) V2 resubmitted to Programme for assurance | milestone, manual | 0d | 2023-07-27 A | 2023-07-27 A | 214FS+9d | 100% | 2023-07-27 | 2023-07-27 | 0d |  |  |  |  | PP | SI Test | 5.4 |  | Design, Build & Test (PIT) | Complete | COMPLETE |  |  |  |  |
| 216 | 1.3.6.3.1.2.4 | Elexon Central Systems Test Approach & Plan (PIT) V3 resubmitted to Programme for assurance | milestone | 0d | 2023-08-18 A | 2023-08-18 A | 215FS+17d | 100% | 2023-08-18 | 2023-08-18 | 0d |  |  |  |  | PP | SI Test | 5.4 |  | Design, Build & Test (PIT) | Complete | COMPLETE |  |  |  |  |
| 217 | 1.3.6.3.1.2.5 | Elexon Central Systems Test approach and plan MHHS Review Completed | milestone | 0d | 2023-09-22 A | 2023-09-22 A | 216FS+25d | 100% | 2023-09-22 | 2023-09-22 | 0d | 2023-07-10 | 2023-07-21 |  |  | SI Test | PP | 5.8 |  | Design, Build & Test (PIT) | Complete | COMPLETE | T3-DB-0106 | SITAG | T3 |  |
| 218 | 1.3.6.3.1.3 | **Test Readiness Report** |  | 16d | 2023-07-28 A | 2023-08-18 A |  | 100% | 2023-07-28 | 2023-08-18 | 51d | 2023-07-21 | 2023-09-29 |  |  | N/A | N/A | 5.0 | N/A | Design, Build & Test (PIT) |  |  |  |  |  |  |
| 219 | 1.3.6.3.1.3.1 | Test readiness reporting |  | 16d | 2023-07-28 A | 2023-08-18 A | 214FS+10d | 100% | 2023-07-28 | 2023-08-18 | 51d | 2023-07-21 | 2023-09-29 |  |  | PP | 109 | 5.0 |  | Design, Build & Test (PIT) | Complete | COMPLETE |  |  |  |  |
| 220 | 1.3.6.3.1.4 | **Requirements to test Traceability Matrix (RTTM)** |  | 35d | 2023-08-04 A | 2023-09-22 A |  | 100% | 2023-08-04 | 2023-09-22 | 35d | 2022-10-31 | 2023-08-18 |  | -0 | N/A | N/A | 5.0 | N/A | Design, Build & Test (PIT) |  |  |  |  |  |  |
| 221 | 1.3.6.3.1.4.1 | Elexon Central Systems RTTM submitted to Programme for assurance | milestone | 0d | 2023-08-04 A | 2023-08-04 A | 214 | 100% | 2023-08-04 | 2023-08-04 | 0d | 2023-08-04 | 2023-08-04 | start no earlier than 2023-04-28 |  | PP | SI Test | 5.0 |  | Design, Build & Test (PIT) | Complete | COMPLETE | T3-DB-0030 | SITAG | T3 | MHHS-ART009 |
| 222 | 1.3.6.3.1.4.2 | Elexon Central Systems RTTM MHHS Review Completed | milestone | 0d | 2023-09-22 A | 2023-09-22 A | 221FS+35d | 100% | 2023-09-22 | 2023-09-22 | 0d | 2023-08-07 | 2023-08-18 |  |  | SI Test | PP | 5.8 |  | Design, Build & Test (PIT) | Complete | COMPLETE | T3-DB-0107 | SITAG | T3 |  |
| 223 | 1.3.6.3.1.5 | **Test Scenarios** |  | 35d | 2023-08-04 A | 2023-09-22 A |  | 100% | 2023-08-04 | 2023-09-22 | 35d | 2022-10-31 | 2023-08-18 |  | -0 | N/A | N/A | 5.0 | N/A | Design, Build & Test (PIT) |  |  |  |  |  |  |
| 224 | 1.3.6.3.1.5.1 | Elexon Central Systems test scenarios submitted to Programme for assurance | milestone | 0d | 2023-08-04 A | 2023-08-04 A | 214 | 100% | 2023-08-04 | 2023-08-04 | 0d | 2023-08-04 | 2023-08-04 |  |  | PP | SI Test | 5.0 |  | Design, Build & Test (PIT) | Complete | COMPLETE | T3-DB-0032 | SITAG | T3 |  |
| 225 | 1.3.6.3.1.5.2 | Elexon Central Systems Test scenarios MHHS Review Completed | milestone | 0d | 2023-09-22 A | 2023-09-22 A | 224FS+35d | 100% | 2023-09-22 | 2023-09-22 | 0d | 2023-08-07 | 2023-08-18 |  |  | SI Test | PP | 5.8 |  | Design, Build & Test (PIT) | Complete | COMPLETE | T3-DB-0108 | SITAG | T3 |  |
| 226 | 1.3.6.3.1.6 | **PIT Execution** |  | 38d | 2023-08-21 A | 2023-10-11 A |  | 100% | 2023-08-21 | 2023-10-11 | 248d | 2022-10-31 | 2023-09-29 |  | -0 | N/A | N/A | 5.0 | N/A | Design, Build & Test (PIT) |  |  |  |  |  |  |
| 227 | 1.3.6.3.1.6.1 | PIT Test Execution Progress Report |  | 18d | 2023-09-04 A | 2023-09-27 A | 219FS+10d | 100% | 2023-09-04 | 2023-09-27 | 235d | 2022-10-31 | 2023-09-22 |  |  | PP | SI Test | 5.1 |  | Design, Build & Test (PIT) | Complete | COMPLETE |  |  |  |  |
| 228 | 1.3.6.3.1.6.2 | Elexon Central Systems PIT Execution |  | 28d | 2023-08-21 A | 2023-09-27 A | 219 | 100% | 2023-08-21 | 2023-09-27 | 240d | 2022-10-31 | 2023-09-29 |  |  | PP | SI Test | 5.1 |  | Design, Build & Test (PIT) | Complete | COMPLETE |  |  |  |  |
| 229 | 1.3.6.3.1.6.3 | Elexon Central Systems PIT Completion Report submitted to Programme for assurance | milestone | 0d | 2023-09-27 A | 2023-09-27 A | 228 | 100% | 2023-09-27 | 2023-09-27 | 0d | 2024-01-05 | 2024-01-05 |  |  | PP | SI Test | 5.8 |  | Design, Build & Test (PIT) | Complete | COMPLETE | T3-DB-0109 | SITAG | T3 |  |
| 230 | 1.3.6.3.1.6.4 | Elexon Central Systems PIT Completion Report MHHS Review Completed | milestone | 0d | 2023-10-11 A | 2023-10-11 A | 222, 225, 227, 229FS+10d, 217 | 100% | 2023-10-11 | 2023-10-11 | 0d |  |  |  |  | SI Test | PP | 5.8 |  | Design, Build & Test (PIT) | Complete | COMPLETE | T3-DB-0110 | SITAG | T3 |  |
| 231 | 1.3.6.3.2 | **DIP DBT CIT (Entering at Interval 1)** |  | 221d | 2023-01-02 A | 2023-11-06 A |  | 100% | 2023-01-02 | 2023-11-06 | 266d | 2022-10-31 | 2023-09-29 |  | -0 | N/A | N/A | 5.0 | N/A | Design, Build & Test (PIT) |  |  |  |  |  |  |
| 232 | 1.3.6.3.2.1 | Design |  | 80d | 2023-01-02 A | 2023-04-21 A |  | 100% | 2023-01-02 | 2023-04-21 | 80d | 2023-01-02 | 2023-04-21 | must start on 2023-01-02 |  | PP | SI Design | 5.0 |  | Design, Build & Test (PIT) | Complete | COMPLETE |  |  |  |  |
| 233 | 1.3.6.3.2.2 | Build |  | 155d | 2023-01-09 A | 2023-08-11 A | 232SS+5d | 100% | 2023-01-09 | 2023-08-11 | 155d | 2023-01-09 | 2023-08-11 |  |  | PP |  | 5.5 |  | Design, Build & Test (PIT) | Complete | COMPLETE |  |  |  |  |
| 234 | 1.3.6.3.2.3 | **Test Approach & Plan** |  | 9d | 2023-07-07 A | 2023-07-20 A |  | 100% | 2023-07-07 | 2023-07-20 | 190d | 2022-10-31 | 2023-07-21 |  |  | N/A | N/A | 5.0 | N/A | Design, Build & Test (PIT) |  |  |  |  |  |  |
| 235 | 1.3.6.3.2.3.1 | DIP Test Approach & Plan (PIT) submitted to Programme for assurance | milestone | 0d | 2023-07-07 A | 2023-07-07 A |  | 100% | 2023-07-07 | 2023-07-07 | 0d | 2023-07-07 | 2023-07-07 |  |  | PP | SI Test | 5.0 |  | Design, Build & Test (PIT) | Complete | COMPLETE | T3-DB-0026 | SITAG | T3 | MHHS-ART073 |
| 236 | 1.3.6.3.2.3.2 | DIP Test Approach & Plan (PIT) MHHS Review Completed | milestone | 0d | 2023-07-20 A | 2023-07-20 A | 235FS+9d | 100% | 2023-07-20 | 2023-07-20 | 10d | 2023-07-10 | 2023-07-21 |  |  | SI Test | PP | 5.0 |  | Design, Build & Test (PIT) | Complete | COMPLETE |  |  |  |  |

Notes:
- 217: 1/9 - to be raised as new T3 at TMAG. Approved at TMAG on 20/9
- 222: 1/9 - to be raised as new T3 at TMAG. Approved at TMAG on 20/9
- 225: 1/9 - to be raised as new T3 at TMAG. Approved at TMAG on 20/9
- 229: 1/9 - to be raised as new T3 at TMAG. Approved at TMAG on 20/9
- 230: 1/9 - to be raised as new T3 at TMAG. Approved at TMAG on 20/9

| ID | WBS | Task | Type | Duration | Start | Finish | Predecessors | Complete | Baseline start | Baseline finish | Baseline duration | Baseline 1 start | Baseline 1 finish | Constraint | Baseline cost | Responsible | Involved | Update Version | MHHS Resource Name | MHHS Programme Phase | Sched Status | RAG | Artefact ID | Milestone ID | Text29 | Tier |
| --- | --- | --- | --- | --- | --- | --- | --- | --- | --- | --- | --- | --- | --- | --- | --- | --- | --- | --- | --- | --- | --- | --- | --- | --- | --- | --- |
| 237 | 1.3.6.3.2.4 | **PIT Test Readiness Report** |  | 31d | 2023-07-21 A | 2023-09-01 A |  | 100% | 2023-07-21 | 2023-09-01 | 51d | 2023-07-21 | 2023-09-29 |  |  | N/A | N/A | 5.0 | N/A | Design, Build & Test (PIT) |  |  |  |  |  |  |
| 238 | 1.3.6.3.2.4.1 | Test readiness reporting |  | 31d | 2023-07-21 A | 2023-09-01 A | 235FS+9d | 100% | 2023-07-21 | 2023-09-01 | 51d | 2023-07-21 | 2023-09-29 |  |  | SI Test | 109 | 5.0 |  | Design, Build & Test (PIT) | Complete | COMPLETE |  |  |  |  |
| 239 | 1.3.6.3.2.5 | **Requirements to test Traceability Matrix (RTTM)** |  | 18d | 2023-08-04 A | 2023-08-30 A |  | 100% | 2023-08-04 | 2023-08-30 | 210d | 2022-10-31 | 2023-08-18 |  |  | N/A | N/A | 5.0 | N/A | Design, Build & Test (PIT) |  |  |  |  |  |  |
| 240 | 1.3.6.3.2.5.1 | DIP RTTM submitted to Programme for assurance | milestone | 0d | 2023-08-04 A | 2023-08-04 A | 235FS+15d | 100% | 2023-08-04 | 2023-08-04 | 0d | 2023-08-04 | 2023-08-04 |  |  | PP | SI Test | 5.6 |  | Design, Build & Test (PIT) | Complete | COMPLETE | MHHS-ART009 | T3-DB-0034 | SITAG | T3 |
| 241 | 1.3.6.3.2.5.2 | DIP RTTM MHHS Review Completed | milestone | 0d | 2023-08-30 A | 2023-08-30 A | 240FS+18d | 100% | 2023-08-30 | 2023-08-30 | 10d | 2023-08-07 | 2023-08-18 |  |  | SI Test | PP | 5.0 |  | Design, Build & Test (PIT) | Complete | COMPLETE |  |  |  |  |
| 242 | 1.3.6.3.2.6 | **Test Scenarios** |  | 22d | 2023-07-31 A | 2023-08-30 A |  | 100% | 2023-07-31 | 2023-08-30 | 206d | 2022-10-31 | 2023-08-18 |  |  | N/A | N/A | 5.0 | N/A | Design, Build & Test (PIT) |  |  |  |  |  |  |
| 243 | 1.3.6.3.2.6.1 | DIP PIT test scenarios submitted to Programme for assurance | milestone | 0d | 2023-07-31 A | 2023-07-31 A | 235FS+15d | 100% | 2023-07-31 | 2023-07-31 | 0d | 2023-08-04 | 2023-08-04 |  |  | PP | SI Test | 5.0 |  | Design, Build & Test (PIT) | Complete | COMPLETE |  | T3-DB-0036 | SITAG | T3 |
| 244 | 1.3.6.3.2.6.2 | DIP Test scenarios MHHS Review Completed | milestone | 0d | 2023-08-30 A | 2023-08-30 A | 243FS+22d | 100% | 2023-08-30 | 2023-08-30 | 10d | 2023-08-07 | 2023-08-18 |  |  | SI Test | PP | 5.0 |  | Design, Build & Test (PIT) | Complete | COMPLETE |  |  |  |  |
| 245 | 1.3.6.3.2.7 | **PIT execution** |  | 50d | 2023-08-29 A | 2023-11-06 A |  | 100% | 2023-08-29 | 2023-11-06 | 47d | 2022-10-31 | 2023-09-29 |  | -0 | N/A | N/A | 5.0 | N/A | Design, Build & Test (PIT) |  |  |  |  |  |  |
| 246 | 1.3.6.3.2.7.1 | PIT Test Execution Progress Report |  | 37d | 2023-09-01 A | 2023-10-23 A | 247FF, 238 | 100% | 2023-09-01 | 2023-10-23 | 37d | 2022-10-31 | 2023-09-22 | start no earlier than 2023-08-29 |  | PP | SI Test | 5.6 |  | Design, Build & Test (PIT) | Complete | COMPLETE |  |  |  |  |
| 247 | 1.3.6.3.2.7.2 | PIT Execution (Interim Release 1) |  | 30d | 2023-08-29 A | 2023-10-09 A |  | 100% | 2023-08-29 | 2023-10-09 | 24d | 2022-10-31 | 2023-09-29 | start no earlier than 2023-08-29 |  | PP | SI Test | 5.6 |  | Design, Build & Test (PIT) | Complete | COMPLETE |  |  |  |  |
| 248 | 1.3.6.3.2.7.3 | PIT Execution (Interim Release 2) |  | 10d | 2023-10-10 A | 2023-10-23 A | 247 | 100% | 2023-10-10 | 2023-10-23 | 10d |  |  |  |  | PP | SI Test | 5.6 |  | Design, Build & Test (PIT) | Complete | COMPLETE |  |  |  |  |
| 249 | 1.3.6.3.2.7.4 | DIP PIT Completion Report (Interim Release 1) submitted to Programme for assurance | milestone | 0d | 2023-10-09 A | 2023-10-09 A | 247 | 100% | 2023-10-09 | 2023-10-09 | 0d | 2024-01-05 | 2024-01-05 |  |  | PP | SI Test | 5.8 |  | Design, Build & Test (PIT) | Complete | COMPLETE |  | T3-DB-0111 | SITAG | T3 |
| 250 | 1.3.6.3.2.7.5 | DIP PIT Completion Report (Interim Release 1) MHHS Review Completed | milestone | 0d | 2023-10-23 A | 2023-10-23 A | 249FS+10d | 100% | 2023-10-23 | 2023-10-23 | 0d |  |  |  |  | SI Test | SI Test | 5.10 |  | Design, Build & Test (PIT) | Complete | COMPLETE |  | T3-DB-0112 | SITAG | T3 |
| 251 | 1.3.6.3.2.7.6 | DIP PIT Completion Report (Interim Release 2) submitted to Programme for assurance | milestone | 0d | 2023-10-23 A | 2023-10-23 A | 248, 246 | 100% | 2023-10-23 | 2023-10-23 | 0d | 2024-01-05 | 2024-01-05 |  |  | PP | SI Test | 5.10 |  | Design, Build & Test (PIT) | Complete | COMPLETE |  | T3-DB-0113 | SITAG | T3 |
| 252 | 1.3.6.3.2.7.7 | DIP PIT Completion Report (Interim Release 2) MHHS Review Completed | milestone | 0d | 2023-11-06 A | 2023-11-06 A | 251FS+10d | 100% | 2023-11-06 | 2023-11-06 | 0d |  |  |  |  | SI Test | SI Test | 5.14 |  | Design, Build & Test (PIT) | Complete | COMPLETE |  | T3-DB-0114 | SITAG | T3 |
| 253 | 1.3.6.3.3 | **DCC (DSP) DBT SIT Functional (Entering at SIT Functional)** |  | 325d | 2022-10-31 A | 2024-01-26 A |  | 100% | 2022-10-31 | 2024-01-26 | 345d | 2022-10-31 | 2024-01-05 |  | -0 | N/A | N/A | 5.18 | N/A | Design, Build & Test (PIT) |  |  |  |  |  |  |
| 254 | 1.3.6.3.3.1 | Design |  | 67d | 2022-10-31 A | 2023-01-31 A |  | 100% | 2022-10-31 | 2023-01-31 | 67d | 2022-10-31 | 2023-01-31 |  |  | PP | SI Design | 5.18 |  | Design, Build & Test (PIT) | Complete | COMPLETE |  |  |  |  |
| 255 | 1.3.6.3.3.2 | **Test Approach & Plan** |  | 20d | 2023-11-17 A | 2023-12-15 A |  | 100% | 2023-11-17 | 2023-12-15 | 20d | 2022-10-31 | 2023-10-27 |  | -0 | N/A | N/A | 5.18 | N/A | Design, Build & Test (PIT) |  |  |  |  |  |  |
| 256 | 1.3.6.3.3.2.1 | DCC Test Approach & Plan (PIT) submitted to Programme for assurance | milestone | 0d | 2023-11-17 A | 2023-11-17 A | 254FS+208d | 100% | 2023-11-17 | 2023-11-17 | 0d | 2023-10-13 | 2023-10-13 |  |  | PP | SI Test | 5.18 |  | Design, Build & Test (PIT) | Complete | COMPLETE |  | T3-DB-0068 | SITAG | T3 |
| 257 | 1.3.6.3.3.2.2 | DCC Test Approach & Plan (PIT) MHHS Review Completed | milestone | 0d | 2023-12-15 A | 2023-12-15 A | 256FS+20d | 100% | 2023-12-15 | 2023-12-15 | 0d | 2023-10-16 | 2023-10-27 |  |  | SI Test | PP | 5.18 |  | Design, Build & Test (PIT) | Complete | COMPLETE |  | T3-DB-0115 | SITAG | T3 |
| 258 | 1.3.6.3.3.3 | **Test Readiness Report** |  | 22d | 2023-12-04 A | 2024-01-02 A |  | 100% | 2023-12-04 | 2024-01-02 | 51d | 2023-10-27 | 2024-01-05 |  |  | N/A | N/A | 5.18 | N/A | Design, Build & Test (PIT) |  |  |  |  |  |  |
| 259 | 1.3.6.3.3.3.1 | Test readiness reporting |  | 22d | 2023-12-04 A | 2024-01-02 A | 256FS+10d | 100% | 2023-12-04 | 2024-01-02 | 51d | 2023-10-27 | 2024-01-05 |  |  | PP | 109 | 5.18 |  | Design, Build & Test (PIT) | Complete | COMPLETE |  |  |  |  |
| 260 | 1.3.6.3.3.4 | **Requirements to test Traceability Matrix (RTTM)** |  | 30d | 2023-12-15 A | 2024-01-26 A |  | 100% | 2023-12-15 | 2024-01-26 | 30d | 2022-10-31 | 2023-11-24 |  | -0 | N/A | N/A | 5.18 | N/A | Design, Build & Test (PIT) |  |  |  |  |  |  |
| 261 | 1.3.6.3.3.4.1 | DCC RTTM submitted to Programme for assurance | milestone | 0d | 2023-12-15 A | 2023-12-15 A | 256FS+20d | 100% | 2023-12-15 | 2023-12-15 | 0d | 2023-11-10 | 2023-11-10 | start no earlier than 2023-04-28 |  | PP | SI Test | 5.18 |  | Design, Build & Test (PIT) | Complete | COMPLETE |  | T3-DB-0074 | SITAG | T3 |
| 262 | 1.3.6.3.3.4.2 | DCC RTTM MHHS Review Completed | milestone | 0d | 2024-01-26 A | 2024-01-26 A | 261FS+30d | 100% | 2024-01-26 | 2024-01-26 | 0d | 2023-11-13 | 2023-11-24 |  |  | SI Test | PP | 5.18 |  | Design, Build & Test (PIT) | Complete | COMPLETE |  | T3-DB-0116 | SITAG | T3 |

Notes:
- 238: Action: 14/8 - Query from RG - IS this an SI Test deliverable or expected to be a DIP deliverable if so be more specific
- 240: RG confirmed Submitted on 10/8/23
- 246: 21/8 - due to complete 9/10 - advised by RG
- 247: 21/8 - due to complete 9/10 - advised by RG
- 248: 21/8 - new line added date are 9/10 - 23/10 - advised by RG.
- 249: 1/9 - to be raised as new T3 at TMAG. Approved at TMAG on 20/9. 9/10 - RG - After discussions with DM it was decided a completion report for IR1 wasn't required as we are entering IR2 ahead of schedule & draft completion report already submitted & assured
- 250: 1/9 - to be raised as new T3 at TMAG. Approved at TMAG on 20/9
- 251: 1/9 - to be raised as new T3 at TMAG. Approved at TMAG on 20/9
- 252: 7/11- Red because further clarity around remaining open low severity defect work off plan requested. No impact. Completed on 8/12 / Guidance: 6/10 - LC - Successor should be SIT Component Integration Testing 1 Preparation Complete but not linked as DIP test completion plus 10 day review breaks logic. Decision will be made to proceed without a conclusion of the report review
- 256: 21/11- Red because not received. Currently no impact. 30/1 - Completed on 26/1
- 257: 1/9 - to be raised as new T3 at TMAG DCC no longer in CIT, new dates relate to SIT Functional. Approved at TMAG on 20/9. 19/12 - Red because not received
- 261: 19/12- Red because not received. 30/1 - Completed on 26/1
- 262: 23/1- Amber because of potential late delivery of RTTM. No impact. No action. 30/1 - Completed on 26/1

| ID | WBS | Task | Type | Duration | Start | Finish | Predecessors | Complete | Baseline start | Baseline finish | Baseline duration | Baseline 1 start | Baseline 1 finish | Constraint | Baseline cost | Responsible | Involved | Update Version | MHHS Resource Name | MHHS Programme Phase | Sched Status | RAG | Milestone ID | Text29 | Tier | Artefact ID |
| --- | --- | --- | --- | --- | --- | --- | --- | --- | --- | --- | --- | --- | --- | --- | --- | --- | --- | --- | --- | --- | --- | --- | --- | --- | --- | --- |
| 263 | 1.3.6.3.3.5 | **Test Scenarios** |  | 30d | 2023-12-15 A | 2024-01-26 A |  | 100% | 2023-12-15 | 2024-01-26 | 30d | 2022-10-31 | 2023-11-24 |  | -0 | N/A | N/A | 5.18 | N/A | Design, Build & Test (PIT) |  |  |  |  |  |  |
| 264 | 1.3.6.3.3.5.1 | DCC test scenarios submitted to Programme for assurance | milestone | 0d | 2023-12-15 A | 2023-12-15 A | 256FS+20d | 100% | 2023-12-15 | 2023-12-15 | 0d | 2023-11-10 | 2023-11-10 |  |  | PP | SI Test | 5.18 |  | Design, Build & Test (PIT) | Complete | COMPLETE | T3-DB-0078 | SITAG | T3 |  |
| 265 | 1.3.6.3.3.5.2 | DCC Test Scenarios MHHS Review Completed | milestone | 0d | 2024-01-26 A | 2024-01-26 A | 264FS+30d | 100% | 2024-01-26 | 2024-01-26 | 0d | 2023-11-13 | 2023-11-24 |  |  | SI Test | PP | 5.18 |  | Design, Build & Test (PIT) | Complete | COMPLETE | T3-DB-0117 | SITAG | T3 |  |
| 266 | 1.3.6.3.4 | **RECCo (EES) DBT CIT (Entering at Interval 6)** |  | 71d | 2023-10-13 A | 2024-01-19 A |  | 100% | 2023-10-13 | 2024-01-19 | 320d | 2022-10-31 | 2024-01-05 |  | -0 | N/A | N/A | 5.0 | N/A | Design, Build & Test (PIT) |  |  |  |  |  |  |
| 267 | 1.3.6.3.4.1 | **Test Approach & Plan** |  | 20d | 2023-10-13 A | 2023-11-09 A |  | 100% | 2023-10-13 | 2023-11-09 | 20d | 2022-10-31 | 2023-10-27 |  | -0 | N/A | N/A | 5.0 | N/A | Design, Build & Test (PIT) |  |  |  |  |  |  |
| 268 | 1.3.6.3.4.1.1 | EES Test Approach & Plan (PIT) submitted to Programme for assurance | milestone | 0d | 2023-10-13 A | 2023-10-13 A |  | 100% | 2023-10-13 | 2023-10-13 | 0d | 2023-10-13 | 2023-10-13 | start no earlier than 2023-10-13 |  | PP | SI Test | 5.8 |  | Design, Build & Test (PIT) | Complete | COMPLETE | T3-DB-0066 | SITAG | T3 |  |
| 269 | 1.3.6.3.4.1.2 | EES Test approach and plan (PIT) MHHS Review Completed | milestone | 0d | 2023-11-09 A | 2023-11-09 A | 268FS+20d | 100% | 2023-11-09 | 2023-11-09 | 0d | 2023-10-16 | 2023-10-27 |  |  | SI Test | PP | 5.8 |  | Design, Build & Test (PIT) | Complete | COMPLETE | T3-DB-0119 | SITAG | T3 |  |
| 270 | 1.3.6.3.4.2 | **Test Readiness Report** |  | 10d | 2023-10-27 A | 2023-11-09 A |  | 100% | 2023-10-27 | 2023-11-09 | 51d | 2023-10-27 | 2024-01-05 |  |  | N/A | N/A | 5.0 | N/A | Design, Build & Test (PIT) |  |  |  |  |  |  |
| 271 | 1.3.6.3.4.2.1 | Test readiness reporting |  | 10d | 2023-10-27 A | 2023-11-09 A | 268FS+10d | 100% | 2023-10-27 | 2023-11-09 | 51d | 2023-10-27 | 2024-01-05 |  |  | PP | 109 | 5.0 |  | Design, Build & Test (PIT) | Complete | COMPLETE |  |  |  |  |
| 272 | 1.3.6.3.4.3 | **Requirements to test Traceability Matrix (RTTM)** |  | 20d | 2023-11-02 A | 2023-11-30 A |  | 100% | 2023-11-02 | 2023-11-30 | 20d | 2022-10-31 | 2023-11-24 |  | -0 | N/A | N/A | 5.0 | N/A | Design, Build & Test (PIT) |  |  |  |  |  |  |
| 273 | 1.3.6.3.4.3.1 | EES RTTM submitted to Programme for assurance | milestone | 0d | 2023-11-02 A | 2023-11-02 A | 268FS+15d | 100% | 2023-11-02 | 2023-11-02 | 0d | 2023-11-10 | 2023-11-10 |  |  | PP | SI Test | 5.8 |  | Design, Build & Test (PIT) | Complete | COMPLETE | T3-DB-0072 | SITAG | T3 | MHHS-ART009 |
| 274 | 1.3.6.3.4.3.2 | EES RTTM MHHS Review Completed | milestone | 0d | 2023-11-30 A | 2023-11-30 A | 273FS+20d | 100% | 2023-11-30 | 2023-11-30 | 0d | 2023-11-13 | 2023-11-24 |  |  | SI Test | PP | 5.14 |  | Design, Build & Test (PIT) | Complete | COMPLETE | T3-DB-0120 | SITAG | T3 |  |
| 275 | 1.3.6.3.4.4 | **Test Scenarios** |  | 20d | 2023-11-02 A | 2023-11-30 A |  | 100% | 2023-11-02 | 2023-11-30 | 20d | 2022-10-31 | 2023-11-24 |  | -0 | N/A | N/A | 5.0 | N/A | Design, Build & Test (PIT) |  |  |  |  |  |  |
| 276 | 1.3.6.3.4.4.1 | EES test scenarios submitted to Programme for assurance | milestone | 0d | 2023-11-02 A | 2023-11-02 A | 268FS+15d | 100% | 2023-11-02 | 2023-11-02 | 0d | 2023-11-10 | 2023-11-10 |  |  | PP | SI Test | 5.8 |  | Design, Build & Test (PIT) | Complete | COMPLETE | T3-DB-0031 | SITAG | T3 |  |
| 277 | 1.3.6.3.4.4.2 | EES Test scenarios MHHS Review Completed | milestone | 0d | 2023-11-30 A | 2023-11-30 A | 276FS+20d | 100% | 2023-11-30 | 2023-11-30 | 0d | 2023-11-13 | 2023-11-24 |  |  | SI Test | PP | 5.14 |  | Design, Build & Test (PIT) | Complete | COMPLETE | T3-DB-0121 | SITAG | T3 |  |
| 278 | 1.3.6.3.4.5 | **PIT execution** |  | 51d | 2023-11-10 A | 2024-01-19 A |  | 100% | 2023-11-10 | 2024-01-19 | 320d | 2022-10-31 | 2024-01-05 |  | -0 | N/A | N/A | 5.0 | N/A | Design, Build & Test (PIT) |  |  |  |  |  |  |
| 279 | 1.3.6.3.4.5.1 | PIT Test Execution Progress Report |  | 41d | 2023-11-10 A | 2024-01-05 A | 271 | 100% | 2023-11-10 | 2024-01-05 | 41d | 2022-10-31 | 2023-12-29 |  |  | PP | SI Test | 5.0 |  | Design, Build & Test (PIT) | Complete | COMPLETE |  |  |  |  |
| 280 | 1.3.6.3.4.5.2 | PIT Execution |  | 41d | 2023-11-10 A | 2024-01-05 A | 276FS+5d | 100% | 2023-11-10 | 2024-01-05 | 310d | 2022-10-31 | 2024-01-05 |  |  | PP | SI Test | 5.0 |  | Design, Build & Test (PIT) | Complete | COMPLETE |  |  |  |  |
| 281 | 1.3.6.3.4.5.3 | EES PIT Completion Report submitted to Programme for assurance | milestone | 0d | 2024-01-05 A | 2024-01-05 A | 279, 280 | 100% | 2024-01-05 | 2024-01-05 | 0d | 2024-01-05 | 2024-01-05 |  |  | PP | SI Test | 5.14 |  | Design, Build & Test (PIT) | Complete | COMPLETE | T3-DB-0122 | SITAG | T3 |  |
| 282 | 1.3.6.3.4.5.4 | EES PIT Completion Report MHHS Review Completed | milestone | 0d | 2024-01-19 A | 2024-01-19 A | 269, 274, 277, 281FS+10d | 100% | 2024-01-19 | 2024-01-19 | 0d |  |  |  |  | SI Test | PP | 5.14 |  | Design, Build & Test (PIT) | Complete | COMPLETE | T3-DB-0123 | SITAG | T3 |  |
| 283 | 1.3.6.3.5 | **Registration Services DBT CIT (Entering at Interval 2)** |  | 70d | 2023-07-28 A | 2023-11-03 A |  | 100% | 2023-07-28 | 2023-11-03 | 70d | 2022-10-31 | 2024-02-28 |  | -0 | N/A | N/A | 5.0 | N/A | Design, Build & Test (PIT) |  |  |  |  |  |  |
| 284 | 1.3.6.3.5.1 | **Test Approach & Plan** |  | 40d | 2023-07-28 A | 2023-09-22 A |  | 100% | 2023-07-28 | 2023-09-22 | 40d | 2022-10-31 | 2023-08-11 |  | -0 | N/A | N/A | 5.0 | N/A | Design, Build & Test (PIT) |  |  |  |  |  |  |
| 285 | 1.3.6.3.5.1.1 | Registration Services Test Approach & Plan (PIT) submitted to Programme for assurance | milestone | 0d | 2023-07-28 A | 2023-07-28 A |  | 100% | 2023-07-28 | 2023-07-28 | 0d | 2023-07-28 | 2023-07-28 |  |  | PP | SI Test | 5.0 |  | Design, Build & Test (PIT) | Complete | COMPLETE | T3-DB-0028 | SITAG | T3 | MHHS-ART073 |
| 286 | 1.3.6.3.5.1.2 | Registration Services Test approach and plan MHHS Review Completed | milestone | 0d | 2023-09-22 A | 2023-09-22 A | 285FS+40d | 100% | 2023-09-22 | 2023-09-22 | 0d | 2023-07-31 | 2023-08-11 |  |  | SI Test | PP | 5.8 |  | Design, Build & Test (PIT) | Complete | COMPLETE | T3-DB-0124 | SITAG | T3 |  |

Notes:
- 264: 5/12- Red because of late delivery of PIT approach and plan. No impact. No action. 30/1 - Completed on 26/1
- 265: 23/1- Amber because of potential late delivery of test scenarios. No impact. No action. 30/1 - Completed on 26/1
- 266: Assumption that Migration/Reverse Migration DBT is not applicable to RECCo.
- 268: 12/9 - TMAG for name change. Approved at TMAG on 20/9. 17/10 - Red because document not yet received. No impact currently. Issuance from RECCo requested
- 269: 1/9 - to be raised as new T3 at TMAG. Approved at TMAG on 20/9. 17/10 - Amber because Late delivery of document plus earlier intervals backlog. Currently no impact
- 273: 7/11 - Red because not submitted. No impact. No action
- 274: 5/12- Red because Assurance conducted. Comments issued and awaiting response. No impact. No action. Completed on 15/12
- 276: 7/11 - Red because not submitted. No impact. No action
- 277: 5/12- Red because Assurance conducted. Comments issued and awaiting response. No impact. No action. Completed on 15/12
- 281: 1/9 - to be raised as new T3 at TMAG. Approved at TMAG on 20/9. 19/12 - Completed on 15/12
- 282: 1/9 - to be raised as new T3 at TMAG. Approved at TMAG on 20/9. 19/12 - Completed on 15/12
- 286: 1/9 - to be raised as new T3 at TMAG. Approved at TMAG on 20/9

| ID | WBS | Task | Type | Duration | Start | Finish | Predecessors | Complete | Remaining | Baseline start | Baseline finish | Baseline duration | Baseline 1 start | Baseline 1 finish | Total slack | Constraint | Baseline cost | Responsible | Involved | Update Version | MHHS Resource Name | MHHS Programme Phase | Sched Status | RAG | Artefact ID | Milestone ID | Text29 | Tier |
| --- | --- | --- | --- | --- | --- | --- | --- | --- | --- | --- | --- | --- | --- | --- | --- | --- | --- | --- | --- | --- | --- | --- | --- | --- | --- | --- | --- | --- |
| 287 | 1.3.6.3.5.2 | **Test Readiness Report** |  | 20d | 2023-08-14 A | 2023-09-08 A |  | 100% |  | 2023-08-14 | 2023-09-08 | 51d | 2023-08-11 | 2023-10-20 |  |  |  | N/A | N/A | 5.0 | N/A | Design, Build & Test (PIT) |  |  |  |  |  |  |
| 288 | 1.3.6.3.5.2.1 | Test readiness reporting |  | 20d | 2023-08-14 A | 2023-09-08 A | 285FS+10d | 100% |  | 2023-08-14 | 2023-09-08 | 51d | 2023-08-11 | 2023-10-20 |  |  |  | PP | 109 | 5.0 |  | Design, Build & Test (PIT) | Complete | COMPLETE |  |  |  |  |
| 289 | 1.3.6.3.5.3 | **Requirements to test Traceability Matrix (RTTM)** |  | 20d | 2023-09-01 A | 2023-09-29 A |  | 100% |  | 2023-09-01 | 2023-09-29 | 20d | 2022-10-31 | 2023-09-15 |  |  | -0 | N/A | N/A | 5.0 | N/A | Design, Build & Test (PIT) |  |  |  |  |  |  |
| 290 | 1.3.6.3.5.3.1 | Registration Services RTTM submitted to Programme for assurance | milestone | 0d | 2023-09-01 A | 2023-09-01 A | 285FS+15d | 100% |  | 2023-09-01 | 2023-09-01 | 0d | 2023-09-01 | 2023-09-01 |  | start no earlier than 2023-04-28 |  | PP | SI Test | 5.6 |  | Design, Build & Test (PIT) | Complete | COMPLETE | MHHS-ART009 | T3-DB-0042 | SITAG | T3 |
| 291 | 1.3.6.3.5.3.2 | Registration Services RTTM MHHS Review Completed | milestone | 0d | 2023-09-29 A | 2023-09-29 A | 290FS+20d | 100% |  | 2023-09-29 | 2023-09-29 | 0d | 2023-09-04 | 2023-09-15 |  |  |  | SI Test | PP | 5.8 |  | Design, Build & Test (PIT) | Complete | COMPLETE |  | T3-DB-0125 | SITAG | T3 |
| 292 | 1.3.6.3.5.4 | **Test Scenarios** |  | 20d | 2023-09-01 A | 2023-09-29 A |  | 100% |  | 2023-09-01 | 2023-09-29 | 20d | 2022-10-31 | 2023-09-15 |  |  | -0 | N/A | N/A | 5.0 | N/A | Design, Build & Test (PIT) |  |  |  |  |  |  |
| 293 | 1.3.6.3.5.4.1 | Registration Services test scenarios submitted to Programme for assurance | milestone | 0d | 2023-09-01 A | 2023-09-01 A | 285FS+15d | 100% |  | 2023-09-01 | 2023-09-01 | 0d | 2023-09-01 | 2023-09-01 |  |  |  | PP | SI Test | 5.6 |  | Design, Build & Test (PIT) | Complete | COMPLETE |  | T3-DB-0044 | SITAG | T3 |
| 294 | 1.3.6.3.5.4.2 | Registration Services Test scenarios MHHS Review Completed | milestone | 0d | 2023-09-29 A | 2023-09-29 A | 293FS+20d | 100% |  | 2023-09-29 | 2023-09-29 | 0d | 2023-09-04 | 2023-09-15 |  |  |  | SI Test | PP | 5.8 |  | Design, Build & Test (PIT) | Complete | COMPLETE |  | T3-DB-0126 | SITAG | T3 |
| 295 | 1.3.6.3.5.5 | **PIT execution** |  | 40d | 2023-09-11 A | 2023-11-03 A |  | 100% |  | 2023-09-11 | 2023-11-03 | 40d | 2023-01-02 | 2023-10-20 |  |  | -0 | N/A | N/A | 5.0 | N/A | Design, Build & Test (PIT) |  |  |  |  |  |  |
| 296 | 1.3.6.3.5.5.1 | PIT Test Execution Progress Report |  | 33d | 2023-09-11 A | 2023-10-25 A | 288 | 100% |  | 2023-09-11 | 2023-10-25 | 30d | 2023-01-02 | 2023-10-13 |  |  |  | PP | SI Test | 5.0 |  | Design, Build & Test (PIT) | Complete | COMPLETE |  |  |  |  |
| 297 | 1.3.6.3.5.5.2 | PIT Execution |  | 30d | 2023-09-11 A | 2023-10-20 A | 293FS+5d | 100% |  | 2023-09-11 | 2023-10-20 | 30d | 2023-01-16 | 2023-10-20 |  |  |  | PP | SI Test | 5.0 |  | Design, Build & Test (PIT) | Complete | COMPLETE |  |  |  |  |
| 298 | 1.3.6.3.5.5.3 | Registration Services PIT (CIT interval 2) Completion Report submitted to Programme for assurance | milestone | 0d | 2023-10-25 A | 2023-10-25 A | 296, 297 | 100% |  | 2023-10-25 | 2023-10-25 | 0d | 2024-01-05 | 2024-01-05 |  |  |  | PP | SI Test | 5.10 |  | Design, Build & Test (PIT) | Complete | COMPLETE |  | T3-DB-0127 | SITAG | T3 |
| 299 | 1.3.6.3.5.5.4 | Registration Services PIT (CIT interval 2) Completion Report MHHS Review Completed | milestone | 0d | 2023-11-03 A | 2023-11-03 A | 286, 291, 294, 298FS+7d | 100% |  | 2023-11-03 | 2023-11-03 | 0d |  |  |  |  |  | SI Test | PP | 5.11 |  | Design, Build & Test (PIT) | Complete | COMPLETE |  | T3-DB-0128 | SITAG | T3 |
| 300 | 1.3.6.4 | **SIT Participants DBT** |  | 356d | 2023-08-11 A | 2024-12-20 |  | 89% | 38.53d | 2023-08-11 | 2024-12-20 | 495d | 2022-10-31 | 2025-03-14 | 125d |  | -0 | N/A | N/A | 5.0 | N/A | Design, Build & Test (PIT) |  |  |  |  |  |  |
| 301 | 1.3.6.4.1 | **All Data Services DBT CIT (Entering at Interval 3)** |  | 71d | 2023-08-11 A | 2023-11-17 A |  | 100% |  | 2023-08-11 | 2023-11-17 | 275d | 2022-10-31 | 2023-11-03 |  |  | -0 | N/A | N/A | 5.0 | N/A | Design, Build & Test (PIT) |  |  |  |  |  |  |
| 302 | 1.3.6.4.1.1 | **Test Approach & Plan** |  | 30d | 2023-08-11 A | 2023-09-21 A |  | 100% |  | 2023-08-11 | 2023-09-21 | 29d | 2022-10-31 | 2023-08-25 |  |  | -0 | N/A | N/A | 5.0 | N/A | Design, Build & Test (PIT) |  |  |  |  |  |  |
| 303 | 1.3.6.4.1.1.1 | All Data Services Test Approach & Plans (PIT) submitted to Programme for assurance | milestone | 0d | 2023-08-11 A | 2023-08-11 A |  | 100% |  | 2023-08-11 | 2023-08-11 | 0d | 2023-08-11 | 2023-08-11 |  | start no earlier than 2023-08-11 |  | PP | SI Test | 5.0 |  | Design, Build & Test (PIT) | Complete | COMPLETE |  | T3-DB-0038 | SITAG | T3 |
| 304 | 1.3.6.4.1.1.2 | All Data Services Test approach and plans MHHS Review Completed | milestone | 0d | 2023-09-21 A | 2023-09-21 A | 303FS+30d | 100% |  | 2023-09-21 | 2023-09-21 | 0d | 2023-08-14 | 2023-08-25 |  |  |  | SI Test | PP | 5.11 |  | Design, Build & Test (PIT) | Complete | COMPLETE |  | T3-DB-0129 | SITAG | T3 |
| 305 | 1.3.6.4.1.2 | **Test Readiness Report** |  | 11d | 2023-08-25 A | 2023-09-08 A |  | 100% |  | 2023-08-25 | 2023-09-08 | 11d | 2023-08-25 | 2023-11-03 |  |  | -0 | N/A | N/A | 5.0 | N/A | Design, Build & Test (PIT) |  |  |  |  |  |  |
| 306 | 1.3.6.4.1.2.1 | Test readiness reporting |  | 11d | 2023-08-25 A | 2023-09-08 A | 303FS+10d | 100% |  | 2023-08-25 | 2023-09-08 | 11d | 2023-08-25 | 2023-11-03 |  |  |  | PP | 109 | 5.0 |  | Design, Build & Test (PIT) | Complete | COMPLETE |  |  |  |  |
| 307 | 1.3.6.4.1.3 | **Requirements to test Traceability Matrix (RTTM)** |  | 7d | 2023-09-20 A | 2023-09-29 A |  | 100% |  | 2023-09-20 | 2023-09-29 | 5d | 2022-10-31 | 2023-10-06 |  |  | -0 | N/A | N/A | 5.0 | N/A | Design, Build & Test (PIT) |  |  |  |  |  |  |
| 308 | 1.3.6.4.1.3.1 | All Data Services RTTMs submitted to Programme for assurance | milestone | 0d | 2023-09-20 A | 2023-09-20 A | 303FS+29d | 100% |  | 2023-09-20 | 2023-09-20 | 0d | 2023-09-22 | 2023-09-22 |  |  |  | PP | SI Test | 5.7 |  | Design, Build & Test (PIT) | Complete | COMPLETE |  | T3-DB-0058 | SITAG | T3 |
| 309 | 1.3.6.4.1.3.2 | All Data Services RTTMs MHHS Review Completed | milestone | 0d | 2023-09-29 A | 2023-09-29 A | 308FS+7d | 100% |  | 2023-09-29 | 2023-09-29 | 0d | 2023-09-25 | 2023-10-06 |  |  |  | SI Test | PP | 5.8 |  | Design, Build & Test (PIT) | Complete | COMPLETE |  | T3-DB-0130 | SITAG | T3 |
| 310 | 1.3.6.4.1.4 | **Test Scenarios** |  | 6d | 2023-09-20 A | 2023-09-28 A |  | 100% |  | 2023-09-20 | 2023-09-28 | 4d | 2022-10-31 | 2023-10-06 |  |  | -0 | N/A | N/A | 5.0 | N/A | Design, Build & Test (PIT) |  |  |  |  |  |  |
| 311 | 1.3.6.4.1.4.1 | All Data Services test scenarios' submitted to Programme for assurance | milestone | 0d | 2023-09-20 A | 2023-09-20 A | 303FS+29d | 100% |  | 2023-09-20 | 2023-09-20 | 0d | 2023-09-22 | 2023-09-22 |  |  |  | PP | SI Test | 5.7 |  | Design, Build & Test (PIT) | Complete | COMPLETE |  | T3-DB-0056 | SITAG | T3 |
| 312 | 1.3.6.4.1.4.2 | All Data Services Test scenarios' MHHS Review Completed | milestone | 0d | 2023-09-28 A | 2023-09-28 A | 311FS+6d | 100% |  | 2023-09-28 | 2023-09-28 | 0d | 2023-09-25 | 2023-10-06 |  |  |  | SI Test | PP | 5.11 |  | Design, Build & Test (PIT) | Complete | COMPLETE |  | T3-DB-0131 | SITAG | T3 |

Notes:
- 291: 1/9 - to be raised as new T3 at TMAG. Approved at TMAG on 20/9. 4/10 - Red because small number of comments still to be resolved, will be completed no later than 3/11 ahead of Interval 2 Readiness Assessment
- 294: 1/9 - to be raised as new T3 at TMAG
- 297: 17/10 - Amber because St Clements assessment. No impact. Being monitored
- 298: 1/9 - to be raised as new T3 at TMAG. Approved at TMAG on 20/9. 24/10 - Red because 3 day delay to SCS PIT completion. No impact to CIT Interval 2.
- 299: 1/9 - to be raised as new T3 at TMAG. Approved at TMAG on 20/9. 17/10 - Amber because St Clements assessment. No impact. Being monitored
- 304: 1/9 - to be raised as new T3 at TMAG. Approved at TMAG on 20/9. Red due to high volume to be reviewed. Date change under consideration. Review will be completed no later than 17/11 ahead of Interval 3 Readiness Assessment
- 309: 1/9 - to be raised as new T3 at TMAG Approved at TMAG on 20/9. Red due to high volume to be reviewed. Date change under consideration. Review will be completed no later than 17/11 ahead of Interval 3 Readiness Assessment
- 312: 1/9 - to be raised as new T3 at TMAG. Approved at TMAG on 20/9. Red due to high volume to be reviewed. Date change under consideration. Review will be completed no later than 17/11 ahead of Interval 3 Readiness Assessment

| ID | WBS | Task | Type | Duration | Start | Finish | Predecessors | Complete | Remaining | Baseline start | Baseline finish | Baseline duration | Baseline 1 start | Baseline 1 finish | Total slack | Constraint | Baseline cost | Responsible | Involved | Update Version | MHHS Resource Name | MHHS Programme Phase | Sched Status | RAG | Milestone ID | Text29 | Tier | Artefact ID |
| --- | --- | --- | --- | --- | --- | --- | --- | --- | --- | --- | --- | --- | --- | --- | --- | --- | --- | --- | --- | --- | --- | --- | --- | --- | --- | --- | --- | --- |
| 313 | 1.3.6.4.1.5 | **PIT execution** |  | 50d | 2023-09-11 A | 2023-11-17 A |  | 100% |  | 2023-09-11 | 2023-11-17 | 275d | 2022-10-31 | 2023-11-03 |  |  | -0 | N/A | N/A | 5.0 | N/A | Design, Build & Test (PIT) |  |  |  |  |  |  |
| 314 | 1.3.6.4.1.5.1 | PIT Test Execution Progress Report |  | 40d | 2023-09-11 A | 2023-11-03 A | 306 | 100% |  | 2023-09-11 | 2023-11-03 | 260d | 2022-10-31 | 2023-10-27 |  |  |  | PP | SI Test | 5.0 |  | Design, Build & Test (PIT) | Complete | COMPLETE |  |  |  |  |
| 315 | 1.3.6.4.1.5.2 | PIT Execution |  | 27d | 2023-09-28 A | 2023-11-03 A | 311FS+5d | 100% |  | 2023-09-28 | 2023-11-03 | 265d | 2022-10-31 | 2023-11-03 |  |  |  | PP | SI Test | 5.0 |  | Design, Build & Test (PIT) | Complete | COMPLETE |  |  |  |  |
| 316 | 1.3.6.4.1.5.3 | All Data Services PIT Completion Reports submitted to Programme for assurance | milestone | 0d | 2023-11-03 A | 2023-11-03 A | 314, 315 | 100% |  | 2023-11-03 | 2023-11-03 | 0d | 2024-01-05 | 2024-01-05 |  |  |  | PP | SI Test | 5.11 |  | Design, Build & Test (PIT) | Complete | COMPLETE | T3-DB-0132 | SITAG | T3 |  |
| 317 | 1.3.6.4.1.5.4 | All Data Services PIT Completion Reports MHHS Review Completed | milestone | 0d | 2023-11-17 A | 2023-11-17 A | 304, 309, 312, 316FS+10d | 100% |  | 2023-11-17 | 2023-11-17 | 0d |  |  |  |  |  | SI Test | PP | 5.13 |  | Design, Build & Test (PIT) | Complete | COMPLETE | T3-DB-0133 | SITAG | T3 |  |
| 318 | 1.3.6.4.2 | **All Metering Services DBT CIT (Entering at Interval 4)** |  | 70d | 2023-08-25 A | 2023-12-01 A |  | 100% |  | 2023-08-25 | 2023-12-01 | 285d | 2022-10-31 | 2023-11-17 |  |  | -0 | N/A | N/A | 5.0 | N/A | Design, Build & Test (PIT) |  |  |  |  |  |  |
| 319 | 1.3.6.4.2.1 | **Test Approach & Plan** |  | 40d | 2023-08-25 A | 2023-10-20 A |  | 100% |  | 2023-08-25 | 2023-10-20 | 40d | 2022-10-31 | 2023-09-08 |  |  | -0 | N/A | N/A | 5.0 | N/A | Design, Build & Test (PIT) |  |  |  |  |  |  |
| 320 | 1.3.6.4.2.1.1 | All Metering Services Test Approach & Plans (PIT) submitted to Programme for assurance | milestone | 0d | 2023-08-25 A | 2023-08-25 A |  | 100% |  | 2023-08-25 | 2023-08-25 | 0d | 2023-08-25 | 2023-08-25 |  |  |  | PP | SI Test | 5.6 |  | Design, Build & Test (PIT) | Complete | COMPLETE | T3-DB-0040 | SITAG | T3 |  |
| 321 | 1.3.6.4.2.1.2 | All Metering Services Test approach and plans MHHS Review Completed | milestone | 0d | 2023-10-20 A | 2023-10-20 A | 320FS+40d | 100% |  | 2023-10-20 | 2023-10-20 | 0d | 2023-08-28 | 2023-09-08 |  |  |  | SI Test | PP | 5.8 |  | Design, Build & Test (PIT) | Complete | COMPLETE | T3-DB-0134 | SITAG | T3 |  |
| 322 | 1.3.6.4.2.2 | **Test Readiness Report** |  | 11d | 2023-09-11 A | 2023-09-25 A |  | 100% |  | 2023-09-11 | 2023-09-25 | 51d | 2023-09-08 | 2023-11-17 |  |  |  | N/A | N/A | 5.0 | N/A | Design, Build & Test (PIT) |  |  |  |  |  |  |
| 323 | 1.3.6.4.2.2.1 | Test readiness reporting |  | 11d | 2023-09-11 A | 2023-09-25 A | 320FS+10d | 100% |  | 2023-09-11 | 2023-09-25 | 51d | 2023-09-08 | 2023-11-17 |  |  |  | PP | 109 | 5.0 |  | Design, Build & Test (PIT) | Complete | COMPLETE |  |  |  |  |
| 324 | 1.3.6.4.2.3 | **Requirements to test Traceability Matrix (RTTM)** |  | 30d | 2023-09-15 A | 2023-10-27 A |  | 100% |  | 2023-09-15 | 2023-10-27 | 30d | 2022-10-31 | 2023-09-29 |  |  | -0 | N/A | N/A | 5.0 | N/A | Design, Build & Test (PIT) |  |  |  |  |  |  |
| 325 | 1.3.6.4.2.3.1 | All Metering Services RTTMs submitted to Programme for assurance | milestone | 0d | 2023-09-15 A | 2023-09-15 A | 320FS+15d | 100% |  | 2023-09-15 | 2023-09-15 | 0d | 2023-09-15 | 2023-09-15 |  |  |  | PP | SI Test | 5.8 |  | Design, Build & Test (PIT) | Complete | COMPLETE | T3-DB-0048 | SITAG | T3 | MHHS-ART009 |
| 326 | 1.3.6.4.2.3.2 | All Metering Services MHHS Reviews Completed | milestone | 0d | 2023-10-27 A | 2023-10-27 A | 325FS+30d | 100% |  | 2023-10-27 | 2023-10-27 | 0d | 2023-09-18 | 2023-09-29 |  |  |  | SI Test | PP | 5.13 |  | Design, Build & Test (PIT) | Complete | COMPLETE | T3-DB-0135 | SITAG | T3 |  |
| 327 | 1.3.6.4.2.4 | **Test Scenarios** |  | 30d | 2023-09-15 A | 2023-10-27 A |  | 100% |  | 2023-09-15 | 2023-10-27 | 30d | 2022-10-31 | 2023-09-29 |  |  | -0 | N/A | N/A | 5.0 | N/A | Design, Build & Test (PIT) |  |  |  |  |  |  |
| 328 | 1.3.6.4.2.4.1 | All Metering Services test scenarios' submitted to Programme for assurance | milestone | 0d | 2023-09-15 A | 2023-09-15 A | 320FS+15d | 100% |  | 2023-09-15 | 2023-09-15 | 0d | 2023-09-15 | 2023-09-15 |  |  |  | PP | SI Test | 5.8 |  | Design, Build & Test (PIT) | Complete | COMPLETE | T3-DB-0050 | SITAG | T3 |  |
| 329 | 1.3.6.4.2.4.2 | All Metering Services Test scenarios' MHHS Review Completed | milestone | 0d | 2023-10-27 A | 2023-10-27 A | 328FS+30d | 100% |  | 2023-10-27 | 2023-10-27 | 0d | 2023-09-18 | 2023-09-29 |  |  |  | SI Test | PP | 5.13 |  | Design, Build & Test (PIT) | Complete | COMPLETE | T3-DB-0136 | SITAG | T3 |  |
| 330 | 1.3.6.4.2.5 | **PIT execution** |  | 50d | 2023-09-25 A | 2023-12-01 A |  | 100% |  | 2023-09-25 | 2023-12-01 | 285d | 2022-10-31 | 2023-11-17 |  |  | -0 | N/A | N/A | 5.0 | N/A | Design, Build & Test (PIT) |  |  |  |  |  |  |
| 331 | 1.3.6.4.2.5.1 | PIT Test Execution Progress Report |  | 39d | 2023-09-26 A | 2023-11-17 A | 323 | 100% |  | 2023-09-26 | 2023-11-17 | 39d | 2022-10-31 | 2023-11-10 |  |  |  | PP | SI Test | 5.0 |  | Design, Build & Test (PIT) | Complete | COMPLETE |  |  |  |  |
| 332 | 1.3.6.4.2.5.2 | PIT Execution |  | 40d | 2023-09-25 A | 2023-11-17 A | 328FS+5d | 100% |  | 2023-09-25 | 2023-11-17 | 275d | 2022-10-31 | 2023-11-17 |  |  |  | PP | SI Test | 5.0 |  | Design, Build & Test (PIT) | Complete | COMPLETE |  |  |  |  |
| 333 | 1.3.6.4.2.5.3 | All Metering Services PIT Completion Reports submitted to Programme for assurance | milestone | 0d | 2023-11-17 A | 2023-11-17 A | 331, 332 | 100% |  | 2023-11-17 | 2023-11-17 | 0d | 2024-01-05 | 2024-01-05 |  |  |  | PP | SI Test | 5.13 |  | Design, Build & Test (PIT) | Complete | COMPLETE | T3-DB-0137 | SITAG | T3 |  |
| 334 | 1.3.6.4.2.5.4 | All Metering Services PIT Completion Reports MHHS Review Completed | milestone | 0d | 2023-12-01 A | 2023-12-01 A | 321, 326, 329, 333FS+10d | 100% |  | 2023-12-01 | 2023-12-01 | 0d |  |  |  |  |  | SI Test | PP | 5.13 |  | Design, Build & Test (PIT) | Complete | COMPLETE | T3-DB-0138 | SITAG | T3 |  |
| 335 | 1.3.6.4.3 | **All SIT Programme Participants PIT (SIT Functional)** |  | 286d | 2023-11-17 A | 2024-12-20 |  | 77% | 66.66d | 2023-11-17 | 2024-12-20 | 451d | 2022-12-30 | 2024-02-16 | 125d |  | -0 | N/A | N/A | 5.0 | N/A | Design, Build & Test (PIT) |  |  |  |  |  |  |
| 336 | 1.3.6.4.3.1 | **Test Approach & Plans** |  | 40d | 2023-11-17 A | 2024-01-11 A |  | 100% |  | 2023-11-17 | 2024-01-11 | 40d | 2022-12-30 | 2023-11-30 |  |  | -0 | N/A | N/A | 5.2 | N/A | Design, Build & Test (PIT) |  |  |  |  |  |  |
| 337 | 1.3.6.4.3.1.1 | SIT Functional PIT Test Approach & Plan (PIT) submitted to Programme for assurance | milestone | 0d | 2023-11-17 A | 2023-11-17 A |  | 100% |  | 2023-11-17 | 2023-11-17 | 0d | 2023-11-16 | 2023-11-16 |  | start no earlier than 2023-11-17 |  | PP | SI Test | 5.16 |  | Design, Build & Test (PIT) | Complete | COMPLETE | T3-DB-0093 | SITAG | T3 |  |
| 338 | 1.3.6.4.3.1.2 | All SIT Functional Test approach and plans MHHS Reviews Completed | milestone | 0d | 2024-01-11 A | 2024-01-11 A | 337FS+40d | 100% |  | 2024-01-11 | 2024-01-11 | 0d | 2023-11-17 | 2023-11-30 |  |  |  | SI Test | PP | 5.8 |  | Design, Build & Test (PIT) | Complete | COMPLETE | T3-DB-0139 | SITAG | T3 |  |

Notes:
- 314: 10/10 - LC - red because date in the past, not all participants have provided reports. No impact. No action
- 315: 10/10 - LC - red because date in the past, acceptable for some participants to have not started PIT yet
- 316: 1/9 - to be raised as new T3 at TMAG. Approved at TMAG on 20/9
- 317: 1/9 - to be raised as new T3 at TMAG. Approved at TMAG on 20/9. 21/11-Red because 1 report remains outstanding due to close 22/11. Completed on 22/11
- 321: 7/10 - Red due to high volume to be reviewed. Date change under consideration. Review will be completed no later than 04/12 ahead of Interval 4 Readiness Assessment
- 325: 13/9 - name change at TMAG. Red because 9/10 received. Approved at TMAG on 20/9
- 326: 1/9 - to be raised as new T3 at TMAG. Approved at TMAG on 20/9. 17/10 - Red because assurance reviews open comments remain outstanding. Final reviews will be completed no later than 4/12 ahead of Interval 4 Readiness Report
- 328: 13/9 - name change at TMAG Red because 9/10 . Approved at TMAG on 20/9
- 329: 1/9 - to be raised as new T3 at TMAG. Approved at TMAG on 20/9. 17/10 - Red because assurance reviews open comments remain outstanding. Final reviews will be completed no later than 4/12 ahead of Interval 4 Readiness Report
- 333: 1/9 - to be raised as new T3 at TMAG. Approved at TMAG on 20/9. 21/11-Red because not all test completion reports received. No impact. No action
- 334: 1/9 - to be raised as new T3 at TMAG. Approved at TMAG on 20/9.28/11 - Amber because late delivery of some completion reports impairing ability to conclude on time. Expediting reviews ahead of RA 4
- 337: 12/9 - name change to TMAG. Approved at TMAG on 20/9. 5/12-Red because not all test approach and plans received. Escalated at FTIG and PSG. Completed 4/1/24
- 338: 1/9 - to be raised as new T3 at TMAG. Approved at TMAG on 20/9. 16/1- All remaining / late artefacts now received and reviewed by Programme with feedback provided to PPs. Awaiting PPs final feedback. Approved complete at SITAG on 21/2/24

| ID | WBS | Task | Type | Duration | Start | Finish | Predecessors | Complete | Baseline start | Baseline finish | Baseline duration | Baseline 1 start | Baseline 1 finish | Constraint | Baseline cost | Responsible | Involved | Update Version | MHHS Resource Name | MHHS Programme Phase | Sched Status | RAG | Milestone ID | Text29 | Tier |
| --- | --- | --- | --- | --- | --- | --- | --- | --- | --- | --- | --- | --- | --- | --- | --- | --- | --- | --- | --- | --- | --- | --- | --- | --- | --- |
| 339 | 1.3.6.4.3.2 | **Test Readiness Reports** |  | 11d | 2023-12-01 A | 2023-12-15 A |  | 100% | 2023-12-01 | 2023-12-15 | 51d | 2023-11-30 | 2024-02-08 |  |  | N/A | N/A | 5.2 | N/A | Design, Build & Test (PIT) |  |  |  |  |  |
| 340 | 1.3.6.4.3.2.1 | Test readiness reporting |  | 11d | 2023-12-01 A | 2023-12-15 A | 337FS+10d | 100% | 2023-12-01 | 2023-12-15 | 51d | 2023-11-30 | 2024-02-08 |  |  | PP | 109 | 5.2 |  | Design, Build & Test (PIT) | Complete | COMPLETE |  |  |  |
| 341 | 1.3.6.4.3.3 | **Requirements to test Traceability Matrices (RTTM)** |  | 30d | 2023-12-07 A | 2024-01-18 A |  | 100% | 2023-12-07 | 2024-01-18 | 30d | 2023-01-06 | 2024-01-05 |  | -0 | N/A | N/A | 5.2 | N/A | Design, Build & Test (PIT) |  |  |  |  |  |
| 342 | 1.3.6.4.3.3.1 | SIT Functional PIT RTTM submitted to Programme for assurance | milestone | 0d | 2023-12-07 A | 2023-12-07 A | 337FS+15d | 100% | 2023-12-07 | 2023-12-07 | 0d | 2023-12-14 | 2023-12-14 |  |  | PP | SI Test | 5.14 |  | Design, Build & Test (PIT) | Complete | COMPLETE | T3-DB-0091 | SITAG | T3 |
| 343 | 1.3.6.4.3.3.2 | All SIT Functional RTTMs MHHS Reviews Completed | milestone | 0d | 2024-01-18 A | 2024-01-18 A | 342FS+30d | 100% | 2024-01-18 | 2024-01-18 | 0d | 2023-12-15 | 2024-01-05 |  |  | SI Test | PP | 5.14 |  | Design, Build & Test (PIT) | Complete | COMPLETE | T3-DB-0140 | SITAG | T3 |
| 344 | 1.3.6.4.3.4 | **Test Scenarios** |  | 30d | 2023-12-07 A | 2024-01-18 A |  | 100% | 2023-12-07 | 2024-01-18 | 30d | 2023-01-06 | 2024-01-05 |  | -0 | N/A | N/A | 5.2 | N/A | Design, Build & Test (PIT) |  |  |  |  |  |
| 345 | 1.3.6.4.3.4.1 | SIT Functional PIT test scenarios submitted to Programme for assurance | milestone | 0d | 2023-12-07 A | 2023-12-07 A | 337FS+15d | 100% | 2023-12-07 | 2023-12-07 | 0d | 2023-12-14 | 2023-12-14 |  |  | PP | SI Test | 5.14 |  | Design, Build & Test (PIT) | Complete | COMPLETE | T3-DB-0089 | SITAG | T3 |
| 346 | 1.3.6.4.3.4.2 | All SIT Functional Test scenarios' MHHS Reviews Completed | milestone | 0d | 2024-01-18 A | 2024-01-18 A | 345FS+30d | 100% | 2024-01-18 | 2024-01-18 | 0d | 2023-12-15 | 2024-01-05 |  |  | SI Test | PP | 5.14 |  | Design, Build & Test (PIT) | Complete | COMPLETE | T3-DB-0141 | SITAG | T3 |
| 347 | 1.3.6.4.3.5 | **PIT execution** |  | 51d | 2023-12-15 A | 2024-02-23 A |  | 100% | 2023-12-15 | 2024-02-23 | 301d | 2022-12-30 | 2024-02-09 |  | -0 | N/A | N/A | 5.0 | N/A | Design, Build & Test (PIT) |  |  |  |  |  |
| 348 | 1.3.6.4.3.5.1 | PIT Test Execution Progress Reports |  | 40d | 2023-12-18 A | 2024-02-09 A | 340 | 100% | 2023-12-18 | 2024-02-09 | 40d | 2022-12-30 | 2024-02-01 |  |  | PP | SI Test | 5.0 |  | Design, Build & Test (PIT) | Complete | COMPLETE |  |  |  |
| 349 | 1.3.6.4.3.5.2 | PIT Execution |  | 41d | 2023-12-15 A | 2024-02-09 A | 345FS+5d | 100% | 2023-12-15 | 2024-02-09 | 290d | 2022-12-30 | 2024-02-09 |  |  | PP | SI Test | 5.0 |  | Design, Build & Test (PIT) | Complete | COMPLETE |  |  |  |
| 350 | 1.3.6.4.3.5.3 | All SIT Functional PIT Completion Reports submitted to Programme for Assurance | milestone | 0d | 2024-02-09 A | 2024-02-09 A | 348, 349 | 100% | 2024-02-09 | 2024-02-09 | 0d | 2024-01-05 | 2024-01-05 |  |  | PP | SI Test | 5.19 |  | Design, Build & Test (PIT) | Complete | COMPLETE | T3-DB-0087 | SITAG | T3 |
| 351 | 1.3.6.4.3.5.4 | All SIT Functional PIT Completion Reports MHHS Review Completed | milestone | 0d | 2024-02-23 A | 2024-02-23 A | 338, 343, 346, 350FS+10d | 100% | 2024-02-23 | 2024-02-23 | 0d |  |  |  |  | SI Test | PP | 5.19 |  | Design, Build & Test (PIT) | Complete | COMPLETE | T3-DB-0142 | SITAG | T3 |
| 352 | 1.3.6.4.3.6 | **All SIT Programme Participants PIT (SIT Migration)** |  | 71d | 2024-02-16 A | 2024-05-24 A |  | 100% | 2024-02-16 | 2024-05-24 | 301d |  |  |  | -0 | N/A | N/A | 5.1 | N/A | Design, Build & Test (PIT) |  |  |  |  |  |
| 353 | 1.3.6.4.3.6.1 | **Test Approach & Plans** |  | 40d | 2024-02-16 A | 2024-04-11 A |  | 100% | 2024-02-16 | 2024-04-11 | 40d |  |  |  | -0 | N/A | N/A | 5.2 | N/A | Design, Build & Test (PIT) |  |  |  |  |  |
| 354 | 1.3.6.4.3.6.1.1 | All SIT Migration PIT Test Approach & Plans submitted to Programme for assurance | milestone | 0d | 2024-02-16 A | 2024-02-16 A |  | 100% | 2024-02-16 | 2024-02-16 | 0d |  |  | start no earlier than 2024-02-16 |  | PP | SI Test | 5.8 |  | Design, Build & Test (PIT) | Complete | COMPLETE | T3-DB-0143 | SITAG | T3 |
| 355 | 1.3.6.4.3.6.1.2 | All SIT Migration PIT Test approach and plans MHHS Reviews Completed | milestone | 0d | 2024-04-11 A | 2024-04-11 A | 354FS+40d | 100% | 2024-04-11 | 2024-04-11 | 0d |  |  |  |  | SI Test | PP | 5.23 |  | Design, Build & Test (PIT) | Complete | COMPLETE | T3-DB-0144 | SITAG | T3 |
| 356 | 1.3.6.4.3.6.2 | **Test Readiness Reports** |  | 11d | 2024-03-01 A | 2024-03-15 A |  | 100% | 2024-03-01 | 2024-03-15 | 51d |  |  |  |  | N/A | N/A | 5.2 | N/A | Design, Build & Test (PIT) |  |  |  |  |  |
| 357 | 1.3.6.4.3.6.2.1 | Test readiness reporting |  | 11d | 2024-03-01 A | 2024-03-15 A | 354FS+10d | 100% | 2024-03-01 | 2024-03-15 | 51d |  |  |  |  | PP | 109 | 5.2 |  | Design, Build & Test (PIT) | Complete | COMPLETE |  |  |  |
| 358 | 1.3.6.4.3.6.3 | **Requirements to test Traceability Matrices (RTTM)** |  | 30d | 2024-03-07 A | 2024-04-18 A |  | 100% | 2024-03-07 | 2024-04-18 | 30d |  |  |  | -0 | N/A | N/A | 5.2 | N/A | Design, Build & Test (PIT) |  |  |  |  |  |
| 359 | 1.3.6.4.3.6.3.1 | All SIT Migration PIT RTTMs submitted to Programme for assurance | milestone | 0d | 2024-03-07 A | 2024-03-07 A | 354FS+15d | 100% | 2024-03-07 | 2024-03-07 | 0d |  |  |  |  | PP | SI Test | 5.23 |  | Design, Build & Test (PIT) | Complete | COMPLETE | T3-DB-0145 | SITAG | T3 |
| 360 | 1.3.6.4.3.6.3.2 | All SIT Migration RTTMs MHHS Reviews Completed | milestone | 0d | 2024-04-18 A | 2024-04-18 A | 359FS+30d | 100% | 2024-04-18 | 2024-04-18 | 0d |  |  |  |  | SI Test | PP | 5.25 |  | Design, Build & Test (PIT) | Complete | COMPLETE | T3-DB-0146 | SITAG | T3 |
| 361 | 1.3.6.4.3.6.4 | **Test Scenarios** |  | 30d | 2024-03-07 A | 2024-04-18 A |  | 100% | 2024-03-07 | 2024-04-18 | 30d |  |  |  | -0 | N/A | N/A | 5.2 | N/A | Design, Build & Test (PIT) |  |  |  |  |  |
| 362 | 1.3.6.4.3.6.4.1 | All SIT Migration PIT test scenarios submitted to Programme for assurance | milestone | 0d | 2024-03-07 A | 2024-03-07 A | 354FS+15d | 100% | 2024-03-07 | 2024-03-07 | 0d |  |  |  |  | PP | SI Test | 5.23 |  | Design, Build & Test (PIT) | Complete | COMPLETE | T3-DB-0147 | SITAG | T3 |
| 363 | 1.3.6.4.3.6.4.2 | All SIT Migration Test scenarios MHHS Reviews Completed | milestone | 0d | 2024-04-18 A | 2024-04-18 A | 362FS+30d | 100% | 2024-04-18 | 2024-04-18 | 0d |  |  |  |  | SI Test | PP | 5.25 |  | Design, Build & Test (PIT) | Complete | COMPLETE | T3-DB-0148 | SITAG | T3 |

Notes:
- 342: 12/9 - name and date change to TMAG. Approved at TMAG on 20/9. 20/02 - 1 PP artefact not yet received. Escalated at FTIG
- 343: 1/9 - to be raised as new T3 at TMAG. Approved at TMAG on 20/9. 23/01 - Late due to late delivery of PP artefacts for review
- 345: 12/9 - name and date change to TMAG. Approved at TMAG on 20/9. 20/02 - 2 PP artefacts not yet received. Escalated at FTIG
- 346: 1/9 - to be raised as new T3 at TMAG. Approved at TMAG on 20/9. 12/12 - Late due to late delivery of PP artefacts for review
- 348: 16/4: completed 12/4
- 349: 16/4: completed 12/4
- 350: 1/9 - name change at TMAG. Approved at TMAG on 20/9. 20/2 - 23 reports received. The majority of late deliveries have been discussed and agreed with the Programme.5/3 - Approved 1/3 SITAG with work off
- 351: 1/9 - to be raised as new T3 at TMAG. Approved at TMAG on 20/9. 27/2 - Target date missed due to late delivery of some reports. 5/3 - Approved 1/3 SITAG with work off
- 354: 1/9 - to be raised as new T3 at TMAG. Approved at TMAG on 20/9.. 19/3 - 33/35 received
- 355: 1/9 - to be raised as new T3 at TMAG. Approved at TMAG on 20/9. 26/3: At risk because of late delivery of PIT test approach and plans by PPs. 16/4: All received. All but 1 reviewed
- 359: 1/9 - to be raised as new T3 at TMAG. Approved at TMAG on 20/9. 22/04: 33/34 received. Remainder to be chased
- 360: 1/9 - to be raised as new T3 at TMAG. Approved at TMAG on 20/9. 26/3: At risk because of late delivery of RTTMs by PPs 30/4: Late because of late delivery or RTTMS 33/34 reviewed
- 362: 1/9 - to be raised as new T3 at TMAG. Approved at TMAG on 20/9. 22/04: 31/34 received. Remainder to be chased
- 363: 1/9 - to be raised as new T3 at TMAG. Approved at TMAG on 20/9. 26/3: At risk because of late delivery of PIT test scenarios by PPs. 30/4: Late because of late delivery or Test scenarios. 33/34 reviewed

| ID | WBS | Task | Type | Duration | Start | Finish | Predecessors | Complete | Remaining | Baseline start | Baseline finish | Baseline duration | Baseline 1 start | Baseline 1 finish | Total slack | Free slack | Constraint | Baseline cost | Responsible | Involved | Update Version | MHHS Resource Name | MHHS Programme Phase | Sched Status | RAG | Milestone ID | Text29 | Tier | Guidance | Task Status |
| --- | --- | --- | --- | --- | --- | --- | --- | --- | --- | --- | --- | --- | --- | --- | --- | --- | --- | --- | --- | --- | --- | --- | --- | --- | --- | --- | --- | --- | --- | --- |
| 364 | 1.3.6.4.3.6.5 | **PIT execution** |  | 51d | 2024-03-15 A | 2024-05-24 A |  | 100% |  | 2024-03-15 | 2024-05-24 | 301d |  |  |  |  |  | -0 | N/A | N/A | 5.1 | N/A | Design, Build & Test (PIT) |  |  |  |  |  |  |  |
| 365 | 1.3.6.4.3.6.5.1 | PIT Test Execution Progress Reports |  | 40d | 2024-03-18 A | 2024-05-10 A | 357 | 100% |  | 2024-03-18 | 2024-05-10 | 40d |  |  |  |  |  |  | PP | SI Test | 5.1 |  | Design, Build & Test (PIT) | Complete | COMPLETE |  |  |  |  |  |
| 366 | 1.3.6.4.3.6.5.2 | PIT Execution |  | 41d | 2024-03-15 A | 2024-05-10 A | 362FS+5d | 100% |  | 2024-03-15 | 2024-05-10 | 290d |  |  |  |  |  |  | PP | SI Test | 5.1 |  | Design, Build & Test (PIT) | Complete | COMPLETE |  |  |  |  |  |
| 367 | 1.3.6.4.3.6.5.3 | All SIT Migration PIT Completion Reports submitted to Programme for assurance | milestone | 0d | 2024-05-10 A | 2024-05-10 A | 365, 366 | 100% |  | 2024-05-10 | 2024-05-10 | 0d | 2024-01-05 | 2024-01-05 |  |  |  |  | PP | SI Test | 5.8 |  | Design, Build & Test (PIT) | Complete | COMPLETE | T3-DB-0149 | SITAG | T3 |  |  |
| 368 | 1.3.6.4.3.6.5.4 | All SIT Migration PIT Completion Reports MHHS Review Completed | milestone | 0d | 2024-05-24 A | 2024-05-24 A | 355, 360, 363, 367FS+10d | 100% |  | 2024-05-24 | 2024-05-24 | 0d |  |  |  |  |  |  | SI Test | PP | 5.8 |  | Design, Build & Test (PIT) | Complete | COMPLETE | T3-DB-0150 | SITAG | T3 |  |  |
| 369 | 1.3.6.4.3.7 | **All SIT Programme Participants PIT (SIT Non Functional)** |  | 116d | 2024-07-12 A | 2024-12-20 |  | 63% | 42.96d | 2024-07-12 | 2024-12-20 | 301d |  |  | 125d |  |  | -0 | N/A | N/A | 5.1 | N/A | Design, Build & Test (PIT) |  |  |  |  |  |  |  |
| 370 | 1.3.6.4.3.7.1 | **Test Approach & Plan** |  | 41d | 2024-09-27 A | 2024-11-22 |  |  | 41d | 2024-09-27 | 2024-11-22 | 40d |  |  | 145d |  |  | -0 | N/A | N/A | 5.2 | N/A | Design, Build & Test (PIT) |  |  |  |  |  |  |  |
| 371 | 1.3.6.4.3.7.1.1 | SIT Non-Functional PIT Test Approach & Plan (PIT) submitted to Programme for assurance | milestone | 0d | 2024-09-27 A | 2024-09-27 |  | 75% | 0d | 2024-09-27 | 2024-09-27 | 0d |  |  | 0d |  | start no earlier than 2024-05-10 |  | PP | SI Test | 5.30 | Roger Robar | Design, Build & Test (PIT) | Green | GREEN | T3-DB-0151 | SITAG | T3 |  |  |
| 372 | 1.3.6.4.3.7.1.2 | SIT Non-Functional Test approach and plan MHHS Review Completed |  | 1d | 2024-11-21 A | 2024-11-22 | 371FS+40d |  | 1d | 2024-11-21 | 2024-11-22 | 0d |  |  | 145d | 20d |  |  | SI Test | PP | 5.30 | Roger Robar | Design, Build & Test (PIT) | Green | GREEN | T3-DB-0152 | SITAG | T3 | 6/9/24: Approved at esitag on 26/7/24 | 34.33 |
| 373 | 1.3.6.4.3.7.2 | **Test Readiness Report** |  | 13d | 2024-10-04 A | 2024-10-22 |  | 85% | 2d | 2024-10-04 | 2024-10-22 | 51d |  |  | 0d |  |  |  | N/A | N/A | 5.2 | N/A | Design, Build & Test (PIT) |  |  |  |  |  |  |  |
| 374 | 1.3.6.4.3.7.2.1 | Test readiness reporting |  | 13d | 2024-10-04 A | 2024-10-22 | 371FS+10d | 85% | 2d | 2024-10-04 | 2024-10-22 | 51d |  |  | 0d |  |  |  | PP | 109 | 5.2 |  | Design, Build & Test (PIT) | Green | GREEN |  |  |  |  |  |
| 375 | 1.3.6.4.3.7.3 | **Requirements to test Traceability Matrix (RTTM)** |  | 20d | 2024-11-01 A | 2024-11-29 |  |  | 20d | 2024-11-01 | 2024-11-29 | 30d |  |  | 140d |  |  | -0 | N/A | N/A | 5.2 | N/A | Design, Build & Test (PIT) |  |  |  |  |  |  |  |
| 376 | 1.3.6.4.3.7.3.1 | SIT Non-Functional PIT RTTM submitted to Programme for assurance | milestone | 0d | 2024-11-01 A | 2024-11-01 | 371FS+26d | 75% | 0d | 2024-11-01 | 2024-11-01 | 0d |  |  | 140d | 0d |  |  | PP | SI Test | 5.8 | Roger Robar | Design, Build & Test (PIT) | Green | GREEN | T3-DB-0153 | SITAG | T3 |  |  |
| 377 | 1.3.6.4.3.7.3.2 | SIT Non-Functional RTTM MHHS Review Completed | milestone | 0d | 2024-11-29 | 2024-11-29 | 376FS+20d |  |  | 2024-11-29 | 2024-11-29 | 0d |  |  | 140d | 15d | start no earlier than 2024-11-29 |  | SI Test | PP | 5.8 | Roger Robar | Design, Build & Test (PIT) | Green | GREEN | T3-DB-0154 | SITAG | T3 |  | 42.71 |
| 378 | 1.3.6.4.3.7.4 | **Test Scenarios** |  | 20d | 2024-11-01 | 2024-11-29 |  |  |  | 2024-11-01 | 2024-11-29 | 30d |  |  | 0d |  |  | -0 | N/A | N/A | 5.2 | N/A | Design, Build & Test (PIT) |  |  |  |  |  |  |  |
| 379 | 1.3.6.4.3.7.4.1 | SIT Non-Functional PIT test scenarios submitted to Programme for assurance | milestone | 0d | 2024-11-01 | 2024-11-01 | 371FS+26d |  |  | 2024-11-01 | 2024-11-01 | 0d |  |  | 0d |  |  |  | PP | SI Test | 5.8 | Roger Robar | Design, Build & Test (PIT) | Green | GREEN | T3-DB-0155 | SITAG | T3 |  | 14.71 |
| 380 | 1.3.6.4.3.7.4.2 | SIT Non-Functional Test scenarios MHHS Review Completed | milestone | 0d | 2024-11-29 | 2024-11-29 | 379FS+20d |  |  | 2024-11-29 | 2024-11-29 | 0d |  |  | 140d | 15d |  |  | SI Test | PP | 5.8 | Roger Robar | Design, Build & Test (PIT) | Green | GREEN | T3-DB-0156 | SITAG | T3 |  | 42.71 |
| 381 | 1.3.6.4.3.7.5 | **PIT execution** |  | 116d | 2024-07-12 A | 2024-12-20 |  | 61% | 45.66d | 2024-07-12 | 2024-12-20 | 301d |  |  | 125d |  |  | -0 | N/A | N/A | 5.1 | N/A | Design, Build & Test (PIT) |  |  |  |  |  |  |  |
| 382 | 1.3.6.4.3.7.5.1 | PIT Test Execution Progress Report |  | 50d | 2024-07-15 A | 2024-11-21 | 374 | 56% | 22d | 2024-07-15 | 2024-11-21 | 39d |  |  | 131d | 6d | finish no earlier than 2024-11-21 |  | PP | SI Test | 5.1 | Roger Robar | Design, Build & Test (PIT) | Green | GREEN |  |  |  |  |  |
| 383 | 1.3.6.4.3.7.5.2 | PIT Execution |  | 44d | 2024-07-12 A | 2024-11-29 | 379FS+5d | 66% | 15d | 2024-07-12 | 2024-11-29 | 290d |  |  | 125d | 0d | finish no earlier than 2024-11-29 |  | PP | SI Test | 5.1 | Roger Robar | Design, Build & Test (PIT) | Green | GREEN |  |  |  |  |  |
| 384 | 1.3.6.4.3.7.5.3 | SIT Non-Functional PIT Completion Report submitted to Programme for assurance | milestone | 0d | 2024-11-29 | 2024-11-29 | 382, 383 |  |  | 2024-11-29 | 2024-11-29 | 0d | 2024-01-05 | 2024-01-05 | 125d | 0d |  |  | PP | SI Test | 5.10 | Roger Robar | Design, Build & Test (PIT) | Green | GREEN | T3-DB-0157 | SITAG | T3 |  | 42.71 |
| 385 | 1.3.6.4.3.7.5.4 | SIT Non-Functional PIT Completion Report MHHS Review Completed | milestone | 0d | 2024-12-20 | 2024-12-20 | 372, 377, 380, 384FS+15d |  |  | 2024-12-20 | 2024-12-20 | 0d |  |  | 125d | 55d |  |  | SI Test | PP | 5.8 | Roger Robar | Design, Build & Test (PIT) | Green | AMBER | T3-DB-0158 | SITAG | T3 |  | 63.71 |
| 386 | 1.3.6.4.3.8 | **All SIT Programme Participants PIT (SIT Operational)** |  | 116d | 2024-07-12 A | 2024-12-20 |  | 46% | 62.41d | 2024-07-12 | 2024-12-20 | 71d |  |  | 87d |  |  | -0 | N/A | N/A | 5.1 | N/A | Design, Build & Test (PIT) |  |  |  |  |  |  |  |
| 387 | 1.3.6.4.3.8.1 | **Test Approach & Plan** |  | 40d | 2024-09-27 | 2024-11-21 |  |  |  | 2024-09-27 | 2024-11-21 | 40d |  |  | 0d |  |  | -0 | N/A | N/A | 5.2 | N/A | Design, Build & Test (PIT) |  |  |  |  |  |  |  |
| 388 | 1.3.6.4.3.8.1.1 | SIT Operational PIT Test Approach & Plan (PIT) submitted to Programme for assurance | milestone | 0d | 2024-09-27 | 2024-09-27 |  |  |  | 2024-09-27 | 2024-09-27 | 0d |  |  | 0d |  | start no earlier than 2024-09-27 |  | PP | SI Test | 5.8 | Roger Robar | Design, Build & Test (PIT) | Green | GREEN | T3-DB-0159 | SITAG | T3 |  | -20.67 |
| 389 | 1.3.6.4.3.8.1.2 | SIT Operational Test approach and plan MHHS Review Completed | milestone | 0d | 2024-11-21 | 2024-11-21 | 388FS+40d |  |  | 2024-11-21 | 2024-11-21 | 0d |  |  | 108d | 21d |  |  | SI Test | PP | 5.8 | Roger Robar | Design, Build & Test (PIT) | Green | AMBER | T3-DB-0160 | SITAG | T3 |  | 34.71 |

Notes:
- 367: Sufficient PIT completion reports on track, some are known to be late. 11/6: 29/33 received. Small number of PPs will be PIT complete late, but before SIT migration. 1 PP will be post SIT Migration start. 11/6: eSITAG approved on 3/6 subject to Work-off
- 368: 1/9 - to be raised as new T3 at TMAG. Approved at TMAG on 20/9. 14/5: Won't deliver to forecast because of late delivery of by some PPs of PIT completion report. 11/6: eSITAG approved on 3/6 subject to Work-off
- 371: 34/34 initial plans have been submitted to the Programme, but still expecting revised plans from some PPs to address feedback given from the Programme, hence why this activity can't be completed yet. Because of the delay to all plans being submitted there is an increased risk to completion of SIT Non-Functional PIT. Re-forecasting the completion date isnt possible as delivery is dependent on the PPs.
- 372: 14/34 test approaches completed. Late because the completion of the review is dependant on the delivery of all of the SIT Non-Functional Test Approach and Plans from the PPs. This increases the risk to SIT Non-Functional PIT completion
- 376: 34/34 RTTMs have been submitted to the Programme. Because of the delay to all RTTMs being submitted there is an increased risk to completion of SIT Non-Functional PIT. Re-forecasting the completion date isnt possible as delivery is dependent on the PPs. Engagement taking place for remaining PPs.
- 377: 17/34 reviewed. As per T3-DB-0153, Status red until remaining RTTMs submitted and reviewed.
- 379: 33/34 test scenarios have been submitted to the Programme. Because of the delay to all test scenarios being submitted there is an increased risk to completion of SIT Non-Functional PIT. Re-forecasting the completion date isnt possible as delivery is depe
- 380: 17/34 scenarios have been completed. Date missed because the completion of the review is dependent on the delivery of all of the SIT Non-Functional Test Scenarios from the PPs. This increases the risk to SIT Non-Functional PIT completion
- 384: 22/34 SIT Non-Functional PIT Completion Reports have been submitted to the Programme. Because of the delay to all Completion Reports being submitted there is an increased risk to completion of SIT Operational PIT. Re-forecasting the completion date isnt possible as delivery is de
- 385: 4/34 reviewed. As per T3-DB-0157. Status red until remaining PIT Test Approach and Plans submitted and reviewed....
- 388: 32/34 test approach and plans have been submitted to the Programme. Because of the delay to all Test Approach and plans being submitted there is an increased risk to completion of SIT Operational PIT. Re-forecasting the completion date isnt possible as delivery is dependent~on the PPs. Engagement taking place for remaining PPs
- 389: 18/34 reviewed. As per T3-DB-0159, Status red until remaining PIT Test Approach and Plans submitted and reviewed.

| ID | WBS | Task | Type | Duration | Start | Finish | Predecessors | Complete | Remaining | Baseline start | Baseline finish | Baseline duration | Baseline 1 start | Baseline 1 finish | Total slack | Free slack | Constraint | Baseline cost | Responsible | Involved | Update Version | MHHS Resource Name | MHHS Programme Phase | Sched Status | RAG | Task Status | Milestone ID | Text29 | Tier | Artefact ID |
| --- | --- | --- | --- | --- | --- | --- | --- | --- | --- | --- | --- | --- | --- | --- | --- | --- | --- | --- | --- | --- | --- | --- | --- | --- | --- | --- | --- | --- | --- | --- |
| 390 | 1.3.6.4.3.8.2 | **Test Readiness Report** |  | 13d | 2024-10-04 A | 2024-10-22 |  | 42% | 7.5d | 2024-10-04 | 2024-10-22 | 51d |  |  | 0d |  |  |  | N/A | N/A | 5.2 | N/A | Design, Build & Test (PIT) |  |  |  |  |  |  |  |
| 391 | 1.3.6.4.3.8.2.1 | Test readiness reporting |  | 13d | 2024-10-04 A | 2024-10-22 | 388FS+10d | 42% | 7.5d | 2024-10-04 | 2024-10-22 | 51d |  |  | 0d |  |  |  | PP | 109 | 5.2 |  | Design, Build & Test (PIT) | Green | GREEN |  |  |  |  |  |
| 392 | 1.3.6.4.3.8.3 | **Requirements to test Traceability Matrix (RTTM)** |  | 20d | 2024-11-01 | 2024-11-29 |  |  |  | 2024-11-01 | 2024-11-29 | 30d |  |  | 102d |  |  | -0 | N/A | N/A | 5.2 | N/A | Design, Build & Test (PIT) |  |  |  |  |  |  |  |
| 393 | 1.3.6.4.3.8.3.1 | SIT Operational PIT RTTM submitted to Programme for assurance | milestone | 0d | 2024-11-01 | 2024-11-01 | 388FS+26d |  |  | 2024-11-01 | 2024-11-01 | 0d |  |  | 102d | 0d |  |  | PP | SI Test | 5.8 | Roger Robar | Design, Build & Test (PIT) | Green | RED | 14.71 | T3-DB-0161 | SITAG | T3 |  |
| 394 | 1.3.6.4.3.8.3.2 | SIT Operational RTTM MHHS Review Completed | milestone | 0d | 2024-11-29 | 2024-11-29 | 393FS+20d |  |  | 2024-11-29 | 2024-11-29 | 0d |  |  | 102d | 15d |  |  | SI Test | PP | 5.8 | Roger Robar | Design, Build & Test (PIT) | Green | AMBER | 42.71 | T3-DB-0162 | SITAG | T3 |  |
| 395 | 1.3.6.4.3.8.4 | **Test Scenarios** |  | 20d | 2024-11-01 | 2024-11-29 |  |  |  | 2024-11-01 | 2024-11-29 | 30d |  |  | 0d |  |  | -0 | N/A | N/A | 5.2 | N/A | Design, Build & Test (PIT) |  |  |  |  |  |  |  |
| 396 | 1.3.6.4.3.8.4.1 | SIT Operational PIT test scenarios submitted to Programme for assurance | milestone | 0d | 2024-11-01 | 2024-11-01 | 388FS+26d |  |  | 2024-11-01 | 2024-11-01 | 0d |  |  | 0d |  |  |  | PP | SI Test | 5.8 | Roger Robar | Design, Build & Test (PIT) | Green | GREEN | 14.71 | T3-DB-0163 | SITAG | T3 |  |
| 397 | 1.3.6.4.3.8.4.2 | SIT Operational Test scenarios MHHS Review Completed | milestone | 0d | 2024-11-29 | 2024-11-29 | 396FS+20d |  |  | 2024-11-29 | 2024-11-29 | 0d |  |  | 102d | 15d |  |  | SI Test | PP | 5.8 | Roger Robar | Design, Build & Test (PIT) | Green | AMBER | 42.71 | T3-DB-0164 | SITAG | T3 |  |
| 398 | 1.3.6.4.3.8.5 | **PIT execution** |  | 116d | 2024-07-12 A | 2024-12-20 |  | 47% | 61.67d | 2024-07-12 | 2024-12-20 | 51d |  |  | 87d |  |  | -0 | N/A | N/A | 5.1 | N/A | Design, Build & Test (PIT) |  |  |  |  |  |  |  |
| 399 | 1.3.6.4.3.8.5.1 | PIT Test Execution Progress Report |  | 40d | 2024-07-15 A | 2024-11-21 | 391 | 45% | 22d | 2024-07-15 | 2024-11-21 | 40d |  |  | 93d | 6d |  |  | PP | SI Test | 5.1 | Roger Robar | Design, Build & Test (PIT) | Green | GREEN |  |  |  |  |  |
| 400 | 1.3.6.4.3.8.5.2 | PIT Execution |  | 39d | 2024-07-12 A | 2024-11-29 | 396 | 49% | 20d | 2024-07-12 | 2024-11-29 | 41d |  |  | 87d | 0d |  |  | PP | SI Test | 5.1 | Roger Robar | Design, Build & Test (PIT) | Green | GREEN |  |  |  |  |  |
| 401 | 1.3.6.4.3.8.5.3 | SIT Operational PIT Completion Report submitted to Programme for assurance | milestone | 0d | 2024-11-29 | 2024-11-29 | 399, 400 |  |  | 2024-11-29 | 2024-11-29 | 0d | 2024-01-05 | 2024-01-05 | 87d | 0d |  |  | PP | SI Test | 5.10 | Roger Robar | Design, Build & Test (PIT) | Green | RED | 42.71 | T3-DB-0165 | SITAG | T3 |  |
| 402 | 1.3.6.4.3.8.5.4 | SIT Operational PIT Completion Report MHHS Review Completed | milestone | 0d | 2024-12-20 | 2024-12-20 | 389, 394, 397, 401FS+15d |  |  | 2024-12-20 | 2024-12-20 | 0d |  |  | 87d | 20d |  |  | SI Test | PP | 5.8 | Roger Robar | Design, Build & Test (PIT) | Green | AMBER | 63.71 | T3-DB-0166 | SITAG | T3 |  |
| 403 | 1.3.6.4.4 | **All Suppliers DBT CIT (Entering at Interval 5)** |  | 71d | 2023-09-15 A | 2023-12-22 A |  | 100% |  | 2023-09-15 | 2023-12-22 | 300d | 2022-10-31 | 2025-03-14 |  |  |  | -0 | N/A | N/A | 5.0 | N/A | Design, Build & Test (PIT) |  |  |  |  |  |  |  |
| 404 | 1.3.6.4.4.1 | **Test Approach & Plan** |  | 20d | 2023-09-15 A | 2023-10-12 A |  | 100% |  | 2023-09-15 | 2023-10-12 | 19d | 2022-10-31 | 2023-09-29 |  |  |  | -0 | N/A | N/A | 5.0 | N/A | Design, Build & Test (PIT) |  |  |  |  |  |  |  |
| 405 | 1.3.6.4.4.1.1 | All SIT Suppliers Test Approach & Plans (PIT) submitted to Programme for assurance | milestone | 0d | 2023-09-15 A | 2023-09-15 A |  | 100% |  | 2023-09-15 | 2023-09-15 | 0d | 2023-09-15 | 2023-09-15 |  |  | start no earlier than 2023-09-15 |  | PP | SI Test | 5.8 |  | Design, Build & Test (PIT) | Complete | COMPLETE |  | T3-DB-0046 | SITAG | T3 |  |
| 406 | 1.3.6.4.4.1.2 | All SIT Suppliers Test Approach & Plans MHHS Review Completed | milestone | 0d | 2023-10-12 A | 2023-10-12 A | 405FS+20d | 100% |  | 2023-10-12 | 2023-10-12 | 0d | 2023-09-18 | 2023-09-29 |  |  |  |  | SI Test | PP | 5.8 |  | Design, Build & Test (PIT) | Complete | COMPLETE |  | T3-DB-0167 | SITAG | T3 |  |
| 407 | 1.3.6.4.4.2 | **Test Readiness Report** |  | 11d | 2023-09-29 A | 2023-10-13 A |  | 100% |  | 2023-09-29 | 2023-10-13 | 51d | 2023-09-29 | 2023-12-08 |  |  |  |  | N/A | N/A | 5.0 | N/A | Design, Build & Test (PIT) |  |  |  |  |  |  |  |
| 408 | 1.3.6.4.4.2.1 | Test readiness reporting |  | 11d | 2023-09-29 A | 2023-10-13 A | 405FS+10d | 100% |  | 2023-09-29 | 2023-10-13 | 51d | 2023-09-29 | 2023-12-08 |  |  |  |  | PP | 109 | 5.0 |  | Design, Build & Test (PIT) | Complete | COMPLETE |  |  |  |  |  |
| 409 | 1.3.6.4.4.3 | **Requirements to test Traceability Matrix (RTTM)** |  | 20d | 2023-10-06 A | 2023-11-03 A |  | 100% |  | 2023-10-06 | 2023-11-03 | 21d | 2022-10-31 | 2023-10-20 |  |  |  | -0 | N/A | N/A | 5.0 | N/A | Design, Build & Test (PIT) |  |  |  |  |  |  |  |
| 410 | 1.3.6.4.4.3.1 | All SIT Suppliers RTTMs submitted to Programme for assurance | milestone | 0d | 2023-10-06 A | 2023-10-06 A | 405FS+16d | 100% |  | 2023-10-06 | 2023-10-06 | 1d | 2023-10-06 | 2023-10-06 |  |  |  |  | PP | SI Test | 5.8 |  | Design, Build & Test (PIT) | Complete | COMPLETE |  | T3-DB-0064 | SITAG | T3 | MHHS-ART009 |
| 411 | 1.3.6.4.4.3.2 | All SIT Suppliers RTTMs MHHS Review Completed | milestone | 0d | 2023-11-03 A | 2023-11-03 A | 410FS+20d | 100% |  | 2023-11-03 | 2023-11-03 | 0d | 2023-10-09 | 2023-10-20 |  |  |  |  | SI Test | PP | 5.14 |  | Design, Build & Test (PIT) | Complete | COMPLETE |  | T3-DB-0168 | SITAG | T3 |  |
| 412 | 1.3.6.4.4.4 | **Test Scenarios** |  | 20d | 2023-10-05 A | 2023-11-02 A |  | 100% |  | 2023-10-05 | 2023-11-02 | 20d | 2022-10-31 | 2023-10-20 |  |  |  | -0 | N/A | N/A | 5.0 | N/A | Design, Build & Test (PIT) |  |  |  |  |  |  |  |
| 413 | 1.3.6.4.4.4.1 | All SIT Suppliers test scenarios' submitted to Programme for assurance | milestone | 0d | 2023-10-05 A | 2023-10-05 A | 405FS+15d | 100% |  | 2023-10-05 | 2023-10-05 | 0d | 2023-10-06 | 2023-10-06 |  |  |  |  | PP | SI Test | 5.8 |  | Design, Build & Test (PIT) | Complete | COMPLETE |  | T3-DB-0037 | SITAG | T3 |  |
| 414 | 1.3.6.4.4.4.2 | All SIT Suppliers Test scenarios' MHHS Review Completed | milestone | 0d | 2023-11-02 A | 2023-11-02 A | 413FS+20d | 100% |  | 2023-11-02 | 2023-11-02 | 0d | 2023-10-09 | 2023-10-20 |  |  |  |  | SI Test | PP | 5.14 |  | Design, Build & Test (PIT) | Complete | COMPLETE |  | T3-DB-0169 | SITAG | T3 |  |

Notes:
- 393: 28/34 SIT Operational PIT RTTMs have been submitted to the Programme. Because of the delay to all RTTMs being submitted there is an increased risk to completion of SIT Operational PIT. Re-forecasting the completion date isnt possible as delivery is depen
- 394: 14/34 reviewed. As per T3-DB-0161. Status red until remaining PIT Test Approach and Plans submitted and reviewed....
- 396: 28/34 SIT Operational PIT test scenarios have been submitted to the Programme. Because of the delay to all SIT Operational PIT test scenarios being submitted there is increased risk to the completion of SIT Operational PIT. Re-forecasting the completion d
- 397: 14/34 reviewed. As per T3-DB-0163. Status red until remaining PIT Test Approach and Plans submitted and reviewed.
- 401: 7/34 submitted. Date at risk because of potential delay to submissions for SIT Operational PIT completion reports. Impact may be a delay to the start of SIT Operational Testing. Programme continuting to work with PPs.
- 402: 0/34 Date missed because of potential delay to submissions for SIT Operational PIT completion reports. Continue engagement with PPs.
- 405: 12/9 - TMAG for name change Red because 7/9 received. Approved at TMAG on 20/9
- 406: 7/11 - Red due to high volume to be reviewed. Date change under consideration. Initial reviews complete. Final review will be completed no later than 08/01/24 ahead of Interval 5 Readiness Assessment
- 410: 12/9 - TMAG for name change. Approved at TMAG on 20/9. 10/10 - Red because small number of RTTMs still outstanding
- 411: 17/10 - Red because open comments still outstanding. Assurance reviews complete. Review will be completed no later than 08/01/24 ahead of Interval 5 Readiness Report . Completed on 14/12
- 413: 12/9 - TMAG for name change. Approved at TMAG on 20/9. 10/10 - Red because small number of Test Scenarios still outstanding
- 414: 1/9 - to be raised as new T3 at TMAG. Approved at TMAG on 20/9. 17/10 - Red due to high volume and backlog to be reviewed. Review will be completed no later than 08/01/24 ahead of Interval 5 Readiness Report. Completed 14/12

| ID | WBS | Task | Type | Duration | Start | Finish | Predecessors | Complete | Actual start | Baseline start | Baseline finish | Baseline duration | Baseline 1 start | Baseline 1 finish | Constraint | Baseline cost | Responsible | Involved | Update Version | MHHS Resource Name | MHHS Programme Phase | Sched Status | RAG | Milestone ID | Text29 | Tier | Artefact ID |
| --- | --- | --- | --- | --- | --- | --- | --- | --- | --- | --- | --- | --- | --- | --- | --- | --- | --- | --- | --- | --- | --- | --- | --- | --- | --- | --- | --- |
| 415 | 1.3.6.4.4.5 | **PIT execution** |  | 51d | 2023-10-13 A | 2023-12-22 A |  | 100% |  | 2023-10-13 | 2023-12-22 | 300d | 2022-10-31 | 2023-12-08 |  | -0 | N/A | N/A | 5.0 | N/A | Design, Build & Test (PIT) |  |  |  |  |  |  |
| 416 | 1.3.6.4.4.5.1 | PIT Test Execution Progress Report |  | 40d | 2023-10-16 A | 2023-12-08 A | 413FS+5d, 408 | 100% |  | 2023-10-16 | 2023-12-08 | 40d | 2022-10-31 | 2023-12-01 |  |  | PP | SI Test | 5.0 |  | Design, Build & Test (PIT) | Complete | COMPLETE |  |  |  |  |
| 417 | 1.3.6.4.4.5.2 | PIT Execution |  | 41d | 2023-10-13 A | 2023-12-08 A | 413FS+5d | 100% |  | 2023-10-13 | 2023-12-08 | 290d | 2022-10-31 | 2023-12-08 |  |  | PP | SI Test | 5.0 |  | Design, Build & Test (PIT) | Complete | COMPLETE |  |  |  |  |
| 418 | 1.3.6.4.4.5.3 | All SIT Suppliers PIT Completion Reports submitted to Programme for assurance | milestone | 0d | 2023-12-08 A | 2023-12-08 A | 417, 416 | 100% |  | 2023-12-08 | 2023-12-08 | 0d | 2024-01-05 | 2024-01-05 |  |  | PP | SI Test | 5.14 |  | Design, Build & Test (PIT) | Complete | COMPLETE | T3-DB-0170 | SITAG | T3 |  |
| 419 | 1.3.6.4.4.5.4 | All SIT Suppliers PIT Completion Reports MHHS Review Completed | milestone | 0d | 2023-12-22 A | 2023-12-22 A | 418FS+10d, 406, 411, 414 | 100% |  | 2023-12-22 | 2023-12-22 | 0d |  |  |  |  | SI Test | PP | 5.14 |  | Design, Build & Test (PIT) | Complete | COMPLETE | T3-DB-0171 | SITAG | T3 |  |
| 420 | 1.3.6.4.5 | **All LDSO Network Operations DBT CIT (Entering at Interval 5)** |  | 71d | 2023-09-15 A | 2023-12-22 A |  | 100% |  | 2023-09-15 | 2023-12-22 | 310d | 2022-10-31 | 2025-03-14 |  | -0 | N/A | N/A | 5.0 | N/A | Design, Build & Test (PIT) |  |  |  |  |  |  |
| 421 | 1.3.6.4.5.1 | **Test Approach & Plan** |  | 71d | 2023-09-15 A | 2023-12-22 A |  | 100% |  | 2023-09-15 | 2023-12-22 | 310d | 2022-10-31 | 2023-08-11 |  | -0 | N/A | N/A | 5.0 | N/A | Design, Build & Test (PIT) |  |  |  |  |  |  |
| 422 | 1.3.6.4.5.1.1 | All Network Operation Test Approach & Plans (PIT) submitted to Programme for assurance | milestone | 0d | 2023-09-15 A | 2023-09-15 A |  | 100% |  | 2023-09-15 | 2023-09-15 | 0d | 2023-07-28 | 2023-07-28 | start no earlier than 2023-09-15 |  | PP | SI Test | 5.8 |  | Design, Build & Test (PIT) | Complete | COMPLETE | T3-DB-0054 | SITAG | T3 |  |
| 423 | 1.3.6.4.5.1.2 | All Network Operation Test Approach & Plans MHHS Review Completed | milestone | 0d | 2023-10-12 A | 2023-10-12 A | 422FS+20d | 100% |  | 2023-10-12 | 2023-10-12 | 0d | 2023-07-31 | 2023-08-11 |  |  | SI Test | PP | 5.8 |  | Design, Build & Test (PIT) | Complete | COMPLETE | T3-DB-0172 | SITAG | T3 |  |
| 424 | 1.3.6.4.5.1.3 | **Test Readiness Report** |  | 11d | 2023-09-29 A | 2023-10-13 A |  | 100% |  | 2023-09-29 | 2023-10-13 | 51d | 2023-08-11 | 2023-10-20 |  |  | N/A | N/A | 5.0 | N/A | Design, Build & Test (PIT) |  |  |  |  |  |  |
| 425 | 1.3.6.4.5.1.3.1 | Test readiness reporting |  | 11d | 2023-09-29 A | 2023-10-13 A | 422FS+10d | 100% |  | 2023-09-29 | 2023-10-13 | 51d | 2023-08-11 | 2023-10-20 |  |  | PP | 109 | 5.0 |  | Design, Build & Test (PIT) | Complete | COMPLETE |  |  |  |  |
| 426 | 1.3.6.4.5.1.4 | **Requirements to test Traceability Matrix (RTTM)** |  | 20d | 2023-10-05 A | 2023-11-02 A |  | 100% |  | 2023-10-05 | 2023-11-02 | 20d | 2022-10-31 | 2023-09-15 |  | -0 | N/A | N/A | 5.0 | N/A | Design, Build & Test (PIT) |  |  |  |  |  |  |
| 427 | 1.3.6.4.5.1.4.1 | All Network Operation RTTMs submitted to Programme for assurance | milestone | 0d | 2023-10-05 A | 2023-10-05 A | 422FS+15d | 100% |  | 2023-10-05 | 2023-10-05 | 0d | 2023-09-01 | 2023-09-01 | start no earlier than 2023-04-28 |  | PP | SI Test | 5.8 |  | Design, Build & Test (PIT) | Complete | COMPLETE | T3-DB-0062 | SITAG | T3 | MHHS-ART009 |
| 428 | 1.3.6.4.5.1.4.2 | All Network Operation RTTMs MHHS Review Completed | milestone | 0d | 2023-11-02 A | 2023-11-02 A | 427FS+20d | 100% |  | 2023-11-02 | 2023-11-02 | 0d | 2023-09-04 | 2023-09-15 |  |  | SI Test | PP | 5.14 |  | Design, Build & Test (PIT) | Complete | COMPLETE | T3-DB-0173 | SITAG | T3 |  |
| 429 | 1.3.6.4.5.1.5 | **Test Scenarios** |  | 20d | 2023-10-05 A | 2023-11-02 A |  | 100% |  | 2023-10-05 | 2023-11-02 | 20d | 2022-10-31 | 2023-09-15 |  | -0 | N/A | N/A | 5.0 | N/A | Design, Build & Test (PIT) |  |  |  |  |  |  |
| 430 | 1.3.6.4.5.1.5.1 | All Network Operation test scenarios' submitted to Programme for assurance | milestone | 0d | 2023-10-05 A | 2023-10-05 A | 422FS+15d | 100% |  | 2023-10-05 | 2023-10-05 | 0d | 2023-09-01 | 2023-09-01 |  |  | PP | SI Test | 5.8 |  | Design, Build & Test (PIT) | Complete | COMPLETE | T3-DB-0011 | SITAG | T3 |  |
| 431 | 1.3.6.4.5.1.5.2 | All Network Operation test scenarios' MHHS Review Completed | milestone | 0d | 2023-11-02 A | 2023-11-02 A | 430FS+20d | 100% |  | 2023-11-02 | 2023-11-02 | 0d | 2023-09-04 | 2023-09-15 |  |  | SI Test | PP | 5.14 |  | Design, Build & Test (PIT) | Complete | COMPLETE | T3-DB-0174 | SITAG | T3 |  |
| 432 | 1.3.6.4.5.1.6 | **PIT execution** |  | 51d | 2023-10-13 A | 2023-12-22 A |  | 100% |  | 2023-10-13 | 2023-12-22 | 310d | 2022-10-31 | 2024-01-05 |  | -0 | N/A | N/A | 5.0 | N/A | Design, Build & Test (PIT) |  |  |  |  |  |  |
| 433 | 1.3.6.4.5.1.6.1 | PIT Test Execution Progress Report |  | 40d | 2023-10-16 A | 2023-12-08 A | 430FS+5d, 425 | 100% |  | 2023-10-16 | 2023-12-08 | 305d | 2022-10-31 | 2023-12-29 |  |  | PP | SI Test | 5.0 |  | Design, Build & Test (PIT) | Complete | COMPLETE |  |  |  |  |
| 434 | 1.3.6.4.5.1.6.2 | PIT Execution |  | 41d | 2023-10-13 A | 2023-12-08 A | 430FS+5d | 100% |  | 2023-10-13 | 2023-12-08 | 310d | 2022-10-31 | 2024-01-05 |  |  | PP | SI Test | 5.0 |  | Design, Build & Test (PIT) | Complete | COMPLETE |  |  |  |  |
| 435 | 1.3.6.4.5.1.6.3 | All Network Operation PIT (CIT interval 5) Completion Reports submitted to Programme for assurance | milestone | 0d | 2023-12-08 A | 2023-12-08 A | 434, 433 | 100% |  | 2023-12-08 | 2023-12-08 | 0d | 2024-01-05 | 2024-01-05 |  |  | PP | SI Test | 5.0 |  | Design, Build & Test (PIT) | Complete | COMPLETE | T3-DB-0175 | SITAG | T3 |  |
| 436 | 1.3.6.4.5.1.6.4 | All Network Operation PIT (CIT interval 5) Completion Reports MHHS Review Completed | milestone | 0d | 2023-12-22 A | 2023-12-22 A | 435FS+10d, 423, 428, 431 | 100% |  | 2023-12-22 | 2023-12-22 | 0d |  |  |  |  | SI Test | PP | 5.15 |  | Design, Build & Test (PIT) | Complete | COMPLETE | T3-DB-0176 | SITAG | T3 |  |
| 437 | 1.3.6.4.6 | **All UMSO DBT CIT (Entering at Interval 6)** |  | 81d | 2023-09-29 | 2024-01-19 A |  | 100% | 2023-10-13 | 2023-09-29 | 2024-01-19 | 320d | 2022-10-31 | 2024-05-13 |  | -0 | N/A | N/A | 5.0 | N/A | Design, Build & Test (PIT) |  |  |  |  |  |  |
| 438 | 1.3.6.4.6.1 | **Test Approach & Plan** |  | 20d | 2023-10-13 A | 2023-11-09 A |  | 100% |  | 2023-10-13 | 2023-11-09 | 40d | 2022-10-31 | 2023-09-29 |  | -0 | N/A | N/A | 5.0 | N/A | Design, Build & Test (PIT) |  |  |  |  |  |  |
| 439 | 1.3.6.4.6.1.1 | All UMSO Test Approach & Plans (PIT) submitted to Programme for assurance | milestone | 0d | 2023-10-13 A | 2023-10-13 A |  | 100% |  | 2023-10-13 | 2023-10-13 | 0d | 2023-09-15 | 2023-09-15 | start no earlier than 2023-10-13 |  | PP | SI Test | 5.11 |  | Design, Build & Test (PIT) | Complete | COMPLETE | T3-DB-0052 | SITAG | T3 |  |
| 440 | 1.3.6.4.6.1.2 | All UMSO Test Approach & Plans MHHS Review Completed | milestone | 0d | 2023-11-09 A | 2023-11-09 A | 439FS+20d | 100% |  | 2023-11-09 | 2023-11-09 | 0d | 2023-09-18 | 2023-09-29 |  |  | SI Test | PP | 5.10 |  | Design, Build & Test (PIT) | Complete | COMPLETE | T3-DB-0177 | SITAG | T3 |  |

Notes:
- 418: 1/9 - to be raised as new T3 at TMAG. Approved at TMAG on 20/9. 12/12 - Red because not all received. No impact as of yet. No action. Completed 12/12
- 419: 1/9 - to be raised as new T3 at TMAG. Approved at TMAG on 20/9. 12/12 - Amber because not all artefacts received. No impact. No action. Completed 15/12
- 422: 12/9 - TMAG for name and date change Red because only received 1/2 test approach and plans. Approved at TMAG on 20/9
- 423: 11/9 - to be raised as new T3 at TMAG. Approved at TMAG on 20/9. Red due to high volume to be reviewed. Date change under consideration. Review will be completed no later than 08/01/24 ahead of Interval 5 Readiness Assessment
- 427: 12/9 - TMAG for name and date change Approved at TMAG on 20/9. 10/10 - Red because 50% of RTTMs outstanding
- 428: 17/10 - Red because open comments still outstanding. Assurance reviews complete. Review will be completed no later than 08/01/24 ahead of Interval 5 Readiness Report . 19/12 - completed 14/12
- 430: 12/9 - TMAG for name and date change. Approved at TMAG on 20/9. 17/10 - Red because currently 50% have been received. Date change under consideration.
- 431: 17/10 - Red because open comments still outstanding. Assurance reviews complete. Review will be completed no later than 08/01/24 ahead of Interval 5 Readiness Assessment . 19/12 - completed 14/12
- 435: 11/9 - to be raised as new T3 at TMAG. Approved at TMAG on 20/9. 19/12 - completed 14/12
- 436: 11/9 - to be raised as new T3 at TMAG. Approved at TMAG on 20/9. 12/12 - Amber because all reviews complete, clarifications are requested
- 439: 12/9 - TMAG for name and date change. Approved at TMAG on 20/9. 17/10 - Red because not all received. Currently no impact. Issuance request sent. Complete 1/11
- 440: To go to TMAG for date change. Approved for date change at TMAG on 23/10/23. 7/11-Amber because of high volume and backlog to be reviewed. Review will be completed no later than 22/01/24 ahead of Interval 6 Readiness Assessment

| ID | WBS | Task | Type | Duration | Start | Finish | Predecessors | Complete | Remaining | Actual start | Actual finish | Baseline start | Baseline finish | Baseline duration | Baseline 1 start | Baseline 1 finish | Total slack | Constraint | Baseline cost | Responsible | Involved | Update Version | MHHS Resource Name | MHHS Programme Phase | Sched Status | RAG | Artefact ID | Milestone ID | Text29 | Tier | Task Status |
| --- | --- | --- | --- | --- | --- | --- | --- | --- | --- | --- | --- | --- | --- | --- | --- | --- | --- | --- | --- | --- | --- | --- | --- | --- | --- | --- | --- | --- | --- | --- | --- |
| 441 | 1.3.6.4.6.2 | **Test Readiness Report** |  | 11d | 2023-09-29 | 2023-10-13 |  | 100% |  | 2023-10-27 | 2023-11-10 | 2023-09-29 | 2023-10-13 | 11d | 2023-09-29 | 2023-12-08 |  |  | -0 | N/A | N/A | 5.0 | N/A | Design, Build & Test (PIT) |  |  |  |  |  |  |  |
| 442 | 1.3.6.4.6.2.1 | Test readiness reporting |  | 11d | 2023-10-27 A | 2023-11-10 A | 439FS+10d | 100% |  |  |  | 2023-10-27 | 2023-11-10 | 11d | 2023-09-29 | 2023-12-08 |  |  |  | PP | 109 | 5.0 |  | Design, Build & Test (PIT) | Complete | COMPLETE |  |  |  |  |  |
| 443 | 1.3.6.4.6.3 | **Requirements to test Traceability Matrix (RTTM)** |  | 20d | 2023-10-05 | 2023-11-01 |  | 100% |  | 2023-11-02 | 2023-11-30 | 2023-10-05 | 2023-11-01 | 20d | 2022-10-31 | 2023-10-20 |  |  | -0 | N/A | N/A | 5.0 | N/A | Design, Build & Test (PIT) |  |  |  |  |  |  |  |
| 444 | 1.3.6.4.6.3.1 | All UMSO RTTMs submitted to Programme for assurance | milestone | 0d | 2023-11-02 A | 2023-11-02 A | 439FS+15d | 100% |  |  |  | 2023-11-02 | 2023-11-02 | 0d | 2023-10-06 | 2023-10-06 |  |  |  | PP | SI Test | 5.12 |  | Design, Build & Test (PIT) | Complete | COMPLETE | MHHS-ART009 | T3-DB-0060 | SITAG | T3 |  |
| 445 | 1.3.6.4.6.3.2 | All UMSO RTTMs MHHS Review Completed | milestone | 0d | 2023-11-30 A | 2023-11-30 A | 444FS+20d | 100% |  |  |  | 2023-11-30 | 2023-11-30 | 0d | 2023-10-09 | 2023-10-20 |  |  |  | SI Test | PP | 5.12 |  | Design, Build & Test (PIT) | Complete | COMPLETE |  | T3-DB-0178 | SITAG | T3 |  |
| 446 | 1.3.6.4.6.4 | **Test Scenarios** |  | 20d | 2023-10-05 | 2023-11-01 |  | 100% |  | 2023-11-02 | 2023-11-30 | 2023-10-05 | 2023-11-01 | 20d | 2022-10-31 | 2023-10-20 |  |  | -0 | N/A | N/A | 5.0 | N/A | Design, Build & Test (PIT) |  |  |  |  |  |  |  |
| 447 | 1.3.6.4.6.4.1 | All UMSO test scenarios' submitted to Programme for assurance | milestone | 0d | 2023-11-02 A | 2023-11-02 A | 439FS+15d | 100% |  |  |  | 2023-11-02 | 2023-11-02 | 0d | 2023-10-06 | 2023-10-06 |  |  |  | PP | SI Test | 5.12 |  | Design, Build & Test (PIT) | Complete | COMPLETE |  | T3-DB-0025 | SITAG | T3 |  |
| 448 | 1.3.6.4.6.4.2 | All UMSO Test scenarios' MHHS Review Completed | milestone | 0d | 2023-11-30 A | 2023-11-30 A | 447FS+20d | 100% |  |  |  | 2023-11-30 | 2023-11-30 | 0d | 2023-10-09 | 2023-10-20 |  |  |  | SI Test | PP | 5.10 |  | Design, Build & Test (PIT) | Complete | COMPLETE |  | T3-DB-0179 | SITAG | T3 |  |
| 449 | 1.3.6.4.6.5 | **PIT execution** |  | 51d | 2023-11-10 A | 2024-01-19 A |  | 100% |  |  |  | 2023-11-10 | 2024-01-19 | 320d | 2022-10-31 | 2023-12-08 |  |  | -0 | N/A | N/A | 5.0 | N/A | Design, Build & Test (PIT) |  |  |  |  |  |  |  |
| 450 | 1.3.6.4.6.5.1 | PIT Test Execution Progress Report |  | 40d | 2023-11-13 A | 2024-01-05 A | 447FS+5d, 442 | 100% |  |  |  | 2023-11-13 | 2024-01-05 | 40d | 2022-10-31 | 2023-12-01 |  |  |  | PP | SI Test | 5.0 |  | Design, Build & Test (PIT) | Complete | COMPLETE |  |  |  |  |  |
| 451 | 1.3.6.4.6.5.2 | PIT Execution |  | 40d | 2023-11-10 A | 2024-01-04 A | 447FS+5d | 100% |  |  |  | 2023-11-10 | 2024-01-04 | 290d | 2022-10-31 | 2023-12-08 |  |  |  | PP | SI Test | 5.0 |  | Design, Build & Test (PIT) | Complete | COMPLETE |  |  |  |  |  |
| 452 | 1.3.6.4.6.5.3 | All UMSO PIT (CIT interval 6) Completion Reports submitted to Programme for assurance | milestone | 0d | 2024-01-05 A | 2024-01-05 A | 451, 450 | 100% |  |  |  | 2024-01-05 | 2024-01-05 | 0d | 2024-01-05 | 2024-01-05 |  |  |  | PP | SI Test | 5.10 |  | Design, Build & Test (PIT) | Complete | COMPLETE |  | T3-DB-0180 | SITAG | T3 |  |
| 453 | 1.3.6.4.6.5.4 | All UMSO PIT (CIT interval 6) Completion Reports MHHS Review Completed | milestone | 0d | 2024-01-19 A | 2024-01-19 A | 440, 445, 448, 452FS+10d | 100% |  |  |  | 2024-01-19 | 2024-01-19 | 0d |  |  |  |  |  | SI Test | PP | 5.10 |  | Design, Build & Test (PIT) | Complete | COMPLETE |  | T3-DB-0181 | SITAG | T3 |  |
| 454 | 1.3.7 | **DBT Monitoring and Assurance** |  | 842d | 2022-10-31 A | 2026-01-20 |  | 64% | 301d |  |  | 2022-10-31 | 2026-01-20 | 842d | 2022-10-31 | 2026-01-19 | 502d |  |  | N/A | N/A | 5.0 | N/A | Design, Build & Test (PIT) |  |  |  |  |  |  |  |
| 455 | 1.3.7.1 | **Planning and DBT Progress Monitoring of PPs** |  | 696d | 2022-10-31 A | 2025-06-30 |  | 67% | 233d |  |  | 2022-10-31 | 2025-06-30 | 696d | 2022-10-31 | 2025-06-30 | 648d |  |  | N/A | N/A | 5.0 | N/A | Design, Build & Test (PIT) |  |  |  |  |  |  | M9 |
| 456 | 1.3.7.1.1 | Monitor Non-SIT PPs Planning and DBT1 progress (to inform confirmation of Qualification Testing Tranche participants milestones) |  | 696d | 2022-10-31 A | 2025-06-30 | 169SS | 67% | 233d |  |  | 2022-10-31 | 2025-06-30 | 696d | 2022-10-31 | 2025-06-30 | 648d |  |  | Code Bodies | SI Test,PPC | 5.0 | Roger Robar | Design, Build & Test (PIT) | Green | GREEN |  |  |  |  |  |
| 457 | 1.3.7.2 | **DBT Progress Monitoring of Consequential Change** |  | 774d | 2023-02-02 A | 2026-01-20 |  | 51% | 379d |  |  | 2023-02-02 | 2026-01-20 | 774d | 2023-02-01 | 2026-01-19 | 502d |  |  | N/A | N/A | 5.0 | N/A | Design, Build & Test (PIT) |  |  |  |  |  |  | M9 |
| 458 | 1.3.7.2.1 | Monitor & report data cleanse progress |  | 774d | 2023-02-02 A | 2026-01-20 |  | 51% | 379d |  |  | 2023-02-02 | 2026-01-20 | 774d | 2023-02-01 | 2026-01-19 | 502d |  |  | SI Test | PPC | 5.0 | Matthew Breen | Design, Build & Test (PIT) | Green | GREEN |  |  |  |  |  |
| 459 | 1.3.7.3 | **Design Assurance** |  | 713d | 2022-11-14 A | 2025-08-06 |  | 71% | 206.27d |  |  | 2022-11-14 | 2025-08-06 | 713d | 2022-11-14 | 2025-08-06 | 621d |  |  | N/A | N/A | 5.0 | N/A | Design, Build & Test (PIT) |  |  |  |  |  |  | M9 |
| 460 | 1.3.7.3.1 | **Design Assurance Readiness Assessment Preparation** |  | 39d | 2023-02-28 A | 2023-04-21 A |  | 100% |  |  |  | 2023-02-28 | 2023-04-21 | 39d | 2023-02-28 | 2023-04-21 |  |  |  | N/A | N/A | 5.0 | N/A | Design, Build & Test (PIT) |  |  |  |  |  |  |  |
| 461 | 1.3.7.3.1.1 | Set up FTIG |  | 15d | 2023-04-03 A | 2023-04-21 A |  | 100% |  |  |  | 2023-04-03 | 2023-04-21 | 15d | 2023-04-03 | 2023-04-21 |  | must start on 2023-04-03 |  | SI Design |  | 5.0 | Paul Pettitt | Design, Build & Test (PIT) | Complete | COMPLETE |  |  |  |  |  |
| 462 | 1.3.7.3.1.2 | Produce Draft Questions |  | 10d | 2023-02-28 A | 2023-03-13 A |  | 100% |  |  |  | 2023-02-28 | 2023-03-13 | 10d | 2023-02-28 | 2023-03-13 |  | must start on 2023-02-28 |  | SI Design |  | 5.0 | Paul Pettitt | Design, Build & Test (PIT) | Complete | COMPLETE |  |  |  |  |  |
| 463 | 1.3.7.3.1.3 | Pilot with SRO |  | 1d | 2023-03-14 A | 2023-03-14 A | 462 | 100% |  |  |  | 2023-03-14 | 2023-03-14 | 1d | 2023-03-14 | 2023-03-14 |  |  |  | SI Design |  | 5.0 | Paul Pettitt | Design, Build & Test (PIT) | Complete | COMPLETE |  |  |  |  |  |
| 464 | 1.3.7.3.1.4 | Finalise questions |  | 10d | 2023-03-15 A | 2023-03-28 A | 463 | 100% |  |  |  | 2023-03-15 | 2023-03-28 | 10d | 2023-03-15 | 2023-03-28 |  |  |  | SI Design |  | 5.0 | Paul Pettitt | Design, Build & Test (PIT) | Complete | COMPLETE |  |  |  |  |  |
| 465 | 1.3.7.3.1.5 | Prepare on-line RA tooling |  | 10d | 2023-03-29 A | 2023-04-11 A | 464 | 100% |  |  |  | 2023-03-29 | 2023-04-11 | 10d | 2023-03-29 | 2023-04-11 |  |  |  | SI Design |  | 5.0 | Paul Pettitt | Design, Build & Test (PIT) | Complete | COMPLETE |  |  |  |  |  |
| 466 | 1.3.7.3.1.6 | Prepare webinar content |  | 5d | 2023-03-20 A | 2023-03-24 A | 462FS+4d | 100% |  |  |  | 2023-03-20 | 2023-03-24 | 5d | 2023-03-20 | 2023-03-24 |  |  |  | SI Design |  | 5.0 | Paul Pettitt | Design, Build & Test (PIT) | Complete | COMPLETE |  |  |  |  |  |
| 467 | 1.3.7.3.1.7 | Conduct webinar |  | 1d | 2023-03-30 A | 2023-03-30 A | 466FS+3d | 100% |  |  |  | 2023-03-30 | 2023-03-30 | 1d | 2023-03-30 | 2023-03-30 |  |  |  | SI Design | PP | 5.0 | Paul Pettitt | Design, Build & Test (PIT) | Complete | COMPLETE |  |  |  |  |  |

Notes:
- 444: 4/10 - Red because baseline date incorrect. To go to TMAG for date change. Approved for date change at TMAG on 23/10/23. 14/11-Red because up to 50% not received. No impact. No action
- 445: 1/9 - to be raised as new T3 at TMAG. Approved at TMAG on 20/9. 4/10 - Red because baseline date incorrect. To go to TMAG for date change. Approved for date change at TMAG on 23/10/23
- 447: Approved at TMAG on 20/9. 4/10 - Red because baseline date incorrect. To go to TMAG for date change. Approved for date change at TMAG on 23/10/23. 7/11-Red because not received. Expected 10/11. No impact No action
- 448: 1/9 - to be raised as new T3 at TMAG. Approved at TMAG on 20/9. 5/12 - Assurance review conducted, but outstanding comments to be addressed
- 452: . 4/10 - Red because baseline date incorrect. To go to TMAG for date change. Approved for date change at TMAG on 23/10/23. 16/1 - Not all completion reports yet received. Completed on 21/2
- 453: Red because baseline date incorrect. To go to TMAG for date change. Approved for date change at TMAG on 23/10/23. 16/01 - Late due to late delivery of PP artefacts for review. Completed on 21/2
- 456: 15/9 - hold in plan until qualification sections updated
- 458: 15/9 - query with John Wiggins where this sits

| ID | WBS | Task | Type | Duration | Start | Finish | Predecessors | Complete | Remaining | Baseline start | Baseline finish | Baseline duration | Baseline 1 start | Baseline 1 finish | Total slack | Constraint | Responsible | Involved | Update Version | MHHS Resource Name | MHHS Programme Phase | Sched Status | RAG | Milestone ID | Text29 | Tier | Artefact ID |
| --- | --- | --- | --- | --- | --- | --- | --- | --- | --- | --- | --- | --- | --- | --- | --- | --- | --- | --- | --- | --- | --- | --- | --- | --- | --- | --- | --- |
| 468 | 1.3.7.3.2 | **Participant Design Assurance Approach** |  | 43d | 2022-11-14 A | 2023-01-11 A |  | 100% |  | 2022-11-14 | 2023-01-11 | 43d | 2022-11-14 | 2023-01-11 |  |  | N/A | N/A | 5.0 | N/A | Design, Build & Test (PIT) |  |  |  |  |  |  |
| 469 | 1.3.7.3.2.1 | Develop document |  | 20d | 2022-11-14 A | 2022-12-09 A | 47FS+10d | 100% |  | 2022-11-14 | 2022-12-09 | 20d | 2022-11-14 | 2022-12-09 |  | start no earlier than 2022-11-14 | SI Design | PP | 5.0 | Paul Pettitt | Design, Build & Test (PIT) | Complete | COMPLETE |  |  |  |  |
| 470 | 1.3.7.3.2.2 | Review document |  | 18d | 2022-12-12 A | 2023-01-04 A | 469 | 100% |  | 2022-12-12 | 2023-01-04 | 18d | 2022-12-12 | 2023-01-04 |  |  | PP | SI Design,IPA | 5.0 | Paul Pettitt | Design, Build & Test (PIT) | Complete | COMPLETE |  |  |  |  |
| 471 | 1.3.7.3.2.3 | Participant Design Assurance Approach approved | milestone | 0d | 2023-01-11 A | 2023-01-11 A | 470FF+5d | 100% |  | 2023-01-11 | 2023-01-11 | 0d | 2023-01-11 | 2023-01-11 |  |  | SI Design | PP | 5.0 | Paul Pettitt | Design, Build & Test (PIT) | Complete | COMPLETE | T3-DB-0012 | DAG | T3 |  |
| 472 | 1.3.7.3.3 | **Phase 1 - SIT Volunteers (Core Providers)** |  | 145d | 2023-04-10 A | 2023-10-27 A |  | 100% |  | 2023-04-10 | 2023-10-27 | 145d | 2023-04-10 | 2023-10-27 |  |  | N/A | N/A | 5.0 | N/A | Design, Build & Test (PIT) |  |  |  |  |  |  |
| 473 | 1.3.7.3.3.1 | Send on-line questionnaire to core capability providers and current SIT volunteers (from Round 3 consultation) |  | 1d | 2023-04-10 A | 2023-04-10 A |  | 100% |  | 2023-04-10 | 2023-04-10 | 1d | 2023-04-10 | 2023-04-10 |  | must start on 2023-04-10 | SI Design | PP | 5.0 | Paul Pettitt | Design, Build & Test (PIT) | Complete | COMPLETE |  |  |  |  |
| 474 | 1.3.7.3.3.2 | Participants Provide Responses to questionnaires |  | 15d | 2023-04-11 A | 2023-05-01 A | 473 | 100% |  | 2023-04-11 | 2023-05-01 | 15d | 2023-04-11 | 2023-05-01 |  |  | PP |  | 5.0 | Paul Pettitt | Design, Build & Test (PIT) | Complete | COMPLETE |  |  |  |  |
| 475 | 1.3.7.3.3.3 | Assess on-line responses and provided evidence |  | 5d | 2023-05-02 A | 2023-05-08 A | 474 | 100% |  | 2023-05-02 | 2023-05-08 | 5d | 2023-05-02 | 2023-05-08 |  |  | SI Design |  | 5.0 | Paul Pettitt | Design, Build & Test (PIT) | Complete | COMPLETE |  |  |  |  |
| 476 | 1.3.7.3.3.4 | Bi-lateral meeting with each responder, to walk and navigate through provided materials |  | 31d | 2023-05-09 A | 2023-06-20 A | 475 | 100% |  | 2023-05-09 | 2023-06-20 | 31d | 2023-05-09 | 2023-06-20 |  |  | SI Design | PP | 5.0 | Paul Pettitt | Design, Build & Test (PIT) | Complete | COMPLETE |  |  |  |  |
| 477 | 1.3.7.3.3.5 | Plan for, create and execute deep dive assurance interviews based on agreed priorities (participants, design areas) |  | 62d | 2023-06-07 A | 2023-08-31 A | 476FS-10d | 100% |  | 2023-06-07 | 2023-08-31 | 62d | 2023-06-07 | 2023-08-01 |  |  | SI Design |  | 5.2 | Paul Pettitt | Design, Build & Test (PIT) | Complete | COMPLETE |  |  |  |  |
| 478 | 1.3.7.3.3.6 | SI endorsement of participants’ design – assurance reports |  | 43d | 2023-08-02 A | 2023-09-29 A | 477FS-22d | 100% |  | 2023-08-02 | 2023-09-29 | 43d | 2023-08-02 | 2023-08-15 |  |  | SI Design |  | 5.2 | Paul Pettitt | Design, Build & Test (PIT) | Complete | COMPLETE |  |  |  |  |
| 479 | 1.3.7.3.3.7 | Post-assurance review of recommendations take-up by assured participants |  | 44d | 2023-08-29 A | 2023-10-27 A | 478SS+19d | 100% |  | 2023-08-29 | 2023-10-27 | 20d | 2023-08-16 | 2023-10-27 |  |  | SI Design |  | 5.2 | Paul Pettitt | Design, Build & Test (PIT) | Complete | COMPLETE |  |  |  |  |
| 480 | 1.3.7.3.3.8 | Phase 1 - SIT Volunteers (Core Providers) complete | milestone | 0d | 2023-10-27 A | 2023-10-27 A | 479 | 100% |  | 2023-10-27 | 2023-10-27 | 0d | 2023-10-27 | 2023-10-27 |  |  | SI Design |  | 5.11 | Paul Pettitt | Design, Build & Test (PIT) | Complete | COMPLETE | T2-DB-0100 | DAG | T2 | MHHS-ART002 |
| 481 | 1.3.7.3.4 | **Phase 2 - SIT all other participants** |  | 143d | 2023-05-08 A | 2023-11-22 A |  | 100% |  | 2023-05-08 | 2023-11-22 | 143d | 2023-05-08 | 2023-11-22 |  |  | N/A | N/A | 5.0 | N/A | Design, Build & Test (PIT) |  |  |  |  |  |  |
| 482 | 1.3.7.3.4.1 | Send on-line questionnaire to core capability providers and current SIT volunteers (from Round 3 consultation) |  | 1d | 2023-05-08 A | 2023-05-08 A |  | 100% |  | 2023-05-08 | 2023-05-08 | 1d | 2023-05-08 | 2023-05-08 |  | must start on 2023-05-08 | SI Design | PP | 5.0 | Paul Pettitt | Design, Build & Test (PIT) | Complete | COMPLETE |  |  |  |  |
| 483 | 1.3.7.3.4.2 | Participants Provide Responses to questionnaires |  | 15d | 2023-05-09 A | 2023-05-29 A | 482 | 100% |  | 2023-05-09 | 2023-05-29 | 15d | 2023-05-09 | 2023-05-29 |  |  | PP |  | 5.0 | Paul Pettitt | Design, Build & Test (PIT) | Complete | COMPLETE |  |  |  |  |
| 484 | 1.3.7.3.4.3 | Assess on-line responses and provided evidence |  | 5d | 2023-05-30 A | 2023-06-05 A | 483 | 100% |  | 2023-05-30 | 2023-06-05 | 5d | 2023-05-30 | 2023-06-05 |  |  | SI Design |  | 5.0 | Paul Pettitt | Design, Build & Test (PIT) | Complete | COMPLETE |  |  |  |  |
| 485 | 1.3.7.3.4.4 | Bi-lateral meeting with each responder, to walk and navigate through provided materials |  | 84d | 2023-06-06 A | 2023-09-29 A | 484 | 100% |  | 2023-06-06 | 2023-09-29 | 84d | 2023-06-06 | 2023-07-18 |  |  | SI Design | PP | 5.2 | Paul Pettitt | Design, Build & Test (PIT) | Complete | COMPLETE |  |  |  |  |
| 486 | 1.3.7.3.4.5 | Plan for, create and execute deep dive assurance interviews based on agreed priorities (participants, design areas) |  | 69d | 2023-06-27 A | 2023-09-29 A | 485SS+15d | 100% |  | 2023-06-27 | 2023-09-29 | 69d | 2023-07-05 | 2023-08-29 |  |  | SI Design |  | 5.2 | Paul Pettitt | Design, Build & Test (PIT) | Complete | COMPLETE |  |  |  |  |
| 487 | 1.3.7.3.4.6 | SI endorsement of participants’ design – assurance reports |  | 54d | 2023-07-18 A | 2023-09-29 A | 486SS+15d | 100% |  | 2023-07-18 | 2023-09-29 | 54d | 2023-08-30 | 2023-09-12 |  |  | SI Design |  | 5.2 | Paul Pettitt | Design, Build & Test (PIT) | Complete | COMPLETE |  |  |  |  |
| 488 | 1.3.7.3.4.7 | Post-assurance review of recommendations take-up by assured participants |  | 73d | 2023-08-14 A | 2023-11-22 A | 487SS+19d | 100% |  | 2023-08-14 | 2023-11-22 | 38d | 2023-09-13 | 2023-11-22 |  |  | SI Design |  | 5.2 | Paul Pettitt | Design, Build & Test (PIT) | Complete | COMPLETE |  |  |  |  |
| 489 | 1.3.7.3.4.8 | SIT PPs design assurance (excl Migration/Reverse Migration) complete | milestone | 0d | 2023-11-22 A | 2023-11-22 A | 488 | 100% |  | 2023-11-22 | 2023-11-22 | 0d | 2023-11-22 | 2023-11-22 |  |  | SI Design |  | 5.11 | Paul Pettitt | Design, Build & Test (PIT) | Complete | COMPLETE | T2-DB-0200 | DAG | T2 | MHHS-ART002 |
| 490 | 1.3.7.3.5 | **Non-SIT PPs design assurance** |  | 445d | 2023-11-23 A | 2025-08-06 |  | 33% | 300d | 2023-11-23 | 2025-08-06 | 445d | 2023-11-23 | 2025-08-06 | 621d |  | N/A | N/A | 5.0 | N/A | Design, Build & Test (PIT) |  |  |  |  |  |  |
| 491 | 1.3.7.3.5.1 | Non-SIT PPs design assurance (risk-based sample) |  | 445d | 2023-11-23 A | 2025-08-06 | 489 | 33% | 300d | 2023-11-23 | 2025-08-06 | 445d | 2023-11-23 | 2025-08-06 | 621d |  | SI Design | PPC | 5.0 | Paul Pettitt | Design, Build & Test (PIT) | Green | GREEN |  |  |  |  |

Notes:
- 480: 16/10 Awaiting the issuing of backlog reports. But no significant design impacts identified. No impact to commencing SIT
- 488: 6/11 - last report sent out 27/10
- 489: 6/11 - last report sent out 27/10

| ID | WBS | Task | Type | Duration | Start | Finish | Predecessors | Complete | Remaining | Baseline start | Baseline finish | Baseline duration | Baseline 1 start | Baseline 1 finish | Total slack | Constraint | Baseline cost | Responsible | Involved | Task Status | Update Version | MHHS Resource Name | MHHS Programme Phase | Sched Status | RAG | Text3 | Artefact ID | Milestone ID | Text29 | Tier |
| --- | --- | --- | --- | --- | --- | --- | --- | --- | --- | --- | --- | --- | --- | --- | --- | --- | --- | --- | --- | --- | --- | --- | --- | --- | --- | --- | --- | --- | --- | --- |
| 492 | 1.3.7.4 | **Test Assurance** |  | 629d | 2023-02-01 A | 2025-06-30 |  | 63% | 233d | 2023-02-01 | 2025-06-30 | 696d | 2022-10-31 | 2025-06-30 | 648d |  |  | N/A | N/A | M9 | 5.0 | N/A | Design, Build & Test (PIT) |  |  |  |  |  |  |  |
| 493 | 1.3.7.4.1 | Non-SIT PPs test assurance |  | 629d | 2023-02-01 A | 2025-06-30 |  | 63% | 233d | 2023-02-01 | 2025-06-30 | 629d | 2023-02-01 | 2025-06-30 | 648d |  |  | Code Bodies | PP,PPC,SI Test |  | 5.0 | Roger Robar | Design, Build & Test (PIT) | Green | GREEN |  |  |  |  |  |
| 494 | 1.3.7.5 | **Pre-Qualification Guidance (PIT Guidance)** |  | 67d | 2022-10-31 A | 2023-01-31 A |  | 100% |  | 2022-10-31 | 2023-01-31 | 67d | 2022-10-31 | 2023-01-31 |  |  |  | N/A | N/A |  | 5.0 | N/A | Design, Build & Test (PIT) |  |  |  |  |  |  |  |
| 495 | 1.3.7.5.1 | Develop document (incl. collaboration with code bodies, as required) |  | 56d | 2022-10-31 A | 2023-01-16 A |  | 100% |  | 2022-10-31 | 2023-01-16 | 56d | 2022-10-31 | 2023-01-16 |  |  |  | SI Test | Code Bodies |  | 5.0 |  | Design, Build & Test (PIT) | Complete | COMPLETE |  |  |  |  |  |
| 496 | 1.3.7.5.2 | Review, update and agree Pre-Qualification Guidance internally |  | 11d | 2023-01-17 A | 2023-01-31 A | 495 | 100% |  | 2023-01-17 | 2023-01-31 | 11d | 2023-01-17 | 2023-01-31 |  |  |  | SRO Function | IPA,SI Test |  | 5.0 |  | Design, Build & Test (PIT) | Complete | COMPLETE |  |  |  |  |  |
| 497 | 1.3.7.6 | **External Programme Dependency Management** |  | 0d | 2022-11-03 A | 2022-11-03 A |  | 100% |  | 2022-11-03 | 2022-11-03 | 0d | 2022-11-03 | 2022-11-03 |  |  |  | N/A | N/A |  | 5.0 | N/A | Design, Build & Test (PIT) |  |  |  |  |  |  |  |
| 498 | 1.3.7.6.1 | **SLC47** |  | 0d | 2022-11-03 A | 2022-11-03 A |  | 100% |  | 2022-11-03 | 2022-11-03 | 0d | 2022-11-03 | 2022-11-03 |  |  |  | N/A | N/A |  | 5.0 | N/A | Design, Build & Test (PIT) |  |  |  |  |  |  |  |
| 499 | 1.3.7.6.1.1 | SLC47 implementation date | milestone | 0d | 2022-11-03 A | 2022-11-03 A |  | 100% |  | 2022-11-03 | 2022-11-03 | 0d | 2022-11-03 | 2022-11-03 |  | start no earlier than 2022-11-03 |  | Ofgem |  |  | 5.0 |  | Design, Build & Test (PIT) | Complete | COMPLETE |  |  |  |  |  |
| 500 | 1.4 | **SYSTEMS INTEGRATION TESTING (SIT)** |  | 910d? | 2022-10-31 A | 2026-04-24 |  | 62% | 349.03d? | 2022-10-31 | 2026-04-24 | 841d | 2022-10-31 | 2026-01-19 |  |  | -0 | N/A | N/A |  |  | N/A | Systems Integration Testing (SIT) |  |  | 1 Aug 2023 - 30 Sep 2024 |  |  |  |  |
| 501 | 1.4.1 | **SIT Preparation** |  | 665d? | 2022-10-31 A | 2025-05-16 |  | 81% | 125.86d? | 2022-10-31 | 2025-05-16 | 611d | 2022-10-31 | 2025-03-10 | 679d |  | -0 | N/A | N/A |  | 5.0 | N/A | Systems Integration Testing (SIT) |  |  |  |  |  |  |  |
| 502 | 1.4.1.1 | **Test Artefact Development** |  | 472d | 2022-10-31 A | 2024-08-21 |  | 99% | 2.69d | 2022-10-31 | 2024-08-21 | 472d | 2022-10-31 | 2023-09-01 | 872d |  | -0 | N/A | N/A | M9 | 5.0 | N/A | Systems Integration Testing (SIT) |  |  |  |  |  |  |  |
| 503 | 1.4.1.1.1 | **Environment Approach & Plan** |  | 460d | 2022-11-16 A | 2024-08-21 A |  | 100% |  | 2022-11-16 | 2024-08-21 | 460d | 2022-11-16 | 2023-06-30 |  |  | -0 | N/A | N/A |  | 5.0 | N/A | Systems Integration Testing (SIT) |  |  |  |  |  |  |  |
| 504 | 1.4.1.1.1.1 | Environment Approach & Plan approved | milestone | 0d | 2022-11-16 A | 2022-11-16 A |  | 100% |  | 2022-11-16 | 2022-11-16 | 0d | 2022-11-16 | 2022-11-16 |  | start no earlier than 2022-11-16 |  | SI Test | PP |  | 5.0 | Simon Berry | Systems Integration Testing (SIT) | Complete | COMPLETE |  | MHHS-ART139 | T3-TE-0010 | SITAG | T3 |
| 505 | 1.4.1.1.1.2 | Environment Approach & Plan - Work Off |  | 157d | 2022-11-17 A | 2023-06-23 A | 504FS+1d | 100% |  | 2022-11-17 | 2023-06-23 | 157d | 2022-11-17 | 2023-06-23 |  |  |  | SI Test | PP |  | 5.0 | Simon Berry | Systems Integration Testing (SIT) | Complete | COMPLETE |  |  |  |  |  |
| 506 | 1.4.1.1.1.3 | Environment Approach & Plan - Work Off Approved | milestone | 0d | 2023-08-16 A | 2023-08-16 A | 505FS+5d | 100% |  | 2023-08-16 | 2023-08-16 | 0d | 2023-06-30 | 2023-06-30 |  | start no earlier than 2023-08-16 |  | SI Test | PP |  | 5.0 | Simon Berry | Systems Integration Testing (SIT) | Complete | COMPLETE |  | MHHS-ART139 | T3-TE-0068 | SITAG | T3 |
| 507 | 1.4.1.1.1.4 | Environment Approach and Plan - SIT Functional | milestone | 0d | 2023-11-20 A | 2023-11-20 A |  | 100% |  | 2023-11-20 | 2023-11-20 | 0d |  |  |  | start no earlier than 2023-11-20 |  | SI Test | PP |  | 5.12 | Simon Berry | Systems Integration Testing (SIT) | Complete | COMPLETE |  | MHHS-DEL 618 | T3-TE-0090 | SITAG | T3 |
| 508 | 1.4.1.1.1.5 | Define Approach to Simulator for Non-SIT LDSO | milestone | 0d | 2023-11-15 A | 2023-11-15 A |  | 100% |  | 2023-11-15 | 2023-11-15 | 0d |  |  |  | start no earlier than 2023-11-15 |  | SI Test | PP |  | 5.12 | Simon Berry |  | Complete | COMPLETE |  |  |  |  |  |
| 509 | 1.4.1.1.1.6 | Environment Approach and Plan - Non SIT LDSO Testing | milestone | 0d | 2024-04-17 A | 2024-04-17 A |  | 100% |  | 2024-04-17 | 2024-04-17 | 0d |  |  |  | start no earlier than 2024-04-17 |  | SI Test | PP |  | 5.22 | Simon Berry | Systems Integration Testing (SIT) | Complete | COMPLETE |  | MHHS-DEL 619 | T3-TE-0091 | SITAG/QAG | T3 |
| 510 | 1.4.1.1.1.7 | Environment Approach and Plan - S and A Testing | milestone | 0d | 2024-07-17 A | 2024-07-17 A |  | 100% |  | 2024-07-17 | 2024-07-17 | 0d |  |  |  | start no earlier than 2024-07-17 |  | SI Test | PP |  | 5.27 | Simon Berry | Systems Integration Testing (SIT) | Complete | COMPLETE |  | MHHS-DEL 619 | T3-TE-0120 | SITAG/QAG | T3 |
| 511 | 1.4.1.1.1.8 | Environment Approach and Plan - SIT Non Functional | milestone | 0d | 2024-06-19 A | 2024-06-19 A |  | 100% |  | 2024-06-19 | 2024-06-19 | 0d |  |  |  | start no earlier than 2024-06-19 |  | SI Test | PP |  | 5.27 | Simon Berry | Systems Integration Testing (SIT) | Complete | COMPLETE |  | MHHS-DEL 620 | T3-TE-0092 | SITAG | T3 |
| 512 | 1.4.1.1.1.9 | Environment Approach and Plan - Sandbox | milestone | 0d | 2024-08-21 A | 2024-08-21 A |  | 100% |  | 2024-08-21 | 2024-08-21 | 0d |  |  |  | start no earlier than 2024-08-21 |  | SI Test | PP |  | 5.27 | Simon Berry | Systems Integration Testing (SIT) | Complete | COMPLETE |  | MHHS-DEL 621 | T3-TE-0093 | SITAG/QAG | T3 |
| 513 | 1.4.1.1.2 | **Overarching Test Scope (for all stages)** |  | 65d | 2022-10-31 A | 2023-01-27 A |  | 100% |  | 2022-10-31 | 2023-01-27 | 175d | 2022-10-31 | 2023-06-30 |  |  |  | N/A | N/A |  | 5.0 | N/A | Systems Integration Testing (SIT) |  |  |  |  |  |  |  |
| 514 | 1.4.1.1.2.1 | **Overarching Test Scope (excl. Migration/Reverse Migration, NFT and Ops components)** |  | 65d | 2022-10-31 A | 2023-01-27 A |  | 100% |  | 2022-10-31 | 2023-01-27 | 65d | 2022-10-31 | 2023-01-27 |  |  |  | N/A | N/A |  | 5.0 | N/A | Systems Integration Testing (SIT) |  |  |  |  |  |  |  |
| 515 | 1.4.1.1.2.1.1 | Develop document (excl Migration/Reverse Migration, NFT and Ops components) |  | 55d | 2022-10-31 A | 2023-01-13 A | 47 | 100% |  | 2022-10-31 | 2023-01-13 | 55d | 2022-10-31 | 2023-01-13 |  |  |  | SI Test |  |  | 5.0 |  | Systems Integration Testing (SIT) | Complete | COMPLETE |  |  |  |  |  |
| 516 | 1.4.1.1.2.1.2 | Review, update & agree document (excl Migration/Reverse Migration, NFT and Ops components) |  | 10d | 2023-01-16 A | 2023-01-27 A | 515 | 100% |  | 2023-01-16 | 2023-01-27 | 10d | 2023-01-16 | 2023-01-27 |  |  |  | SI Test | IPA,Code Bodies,PP |  | 5.0 |  | Systems Integration Testing (SIT) | Complete | COMPLETE |  |  |  |  |  |

Notes:
- 493: 15/9 - keep in plan until qualification reviewed
- 501: Action: 11/3: Ask Simon B for the link (line 1312) dip onboarding to non sit ldso
- 503: Action: 16/8 - add to milestone register. Build out detail further
- 504: Action: 25/7 - Simon to provide update
- 505: Action: 25/7 - Simon to provide update
- 506: Action: 25/7 - Simon to provide update
- 507: The LDSO element is on hold whilst discussions are being held between Programme and Code Bodies re: LDSO testing. When concluded, that update will be re-planned by agreement with TMAG. 20/11- Approved at TMAG / Action: 16/8 - add to milestone register. Build out detail further
- 509: 25/03: To go to Apr QAG for name change as Non-SIT LDSO and S and A will deliver on different timelines so '& S and A' will be removed. 17/4: Approved for name change at SITAG on 17/4/24. / Action: 16/8 - add to milestone register. Build out detail further
- 510: . 25/03: New milestone to go to Apr QAG as Non-SIT LDSO and S and A will deliver on different timelines so need to create a new milestone for S and A. 17/4: Approved as new milestone at SITAG on 17/4/24. 19/6: Approved at SITAG on 19/6 / Action: 16/8 - add to milestone register. Build out detail further
- 511: 26/3/24: To go to April SITAG for date change approval. Because of dependency on NF test approach and plan. Currently under PP review 17/4: Approved date change at SITAG on 17/4/24. 19/6: Approved at SITAG on 19/6 / Action: 16/8 - add to milestone register. Build out detail further
- 512: Name change to remove 'qualification and' to reflect sandbox only scope. Name and date change approved at QAG on 21/3/24. 19/6: Approved at SITAG on 19/6 / Action: 16/8 - add to milestone register. Build out detail further

| ID | WBS | Task | Type | Duration | Start | Finish | Predecessors | Complete | Remaining | Baseline start | Baseline finish | Baseline duration | Baseline 1 start | Baseline 1 finish | Total slack | Constraint | Baseline cost | Responsible | Involved | Task Status | Update Version | MHHS Resource Name | MHHS Programme Phase | Sched Status | RAG | Milestone ID | Text29 | Tier |
| --- | --- | --- | --- | --- | --- | --- | --- | --- | --- | --- | --- | --- | --- | --- | --- | --- | --- | --- | --- | --- | --- | --- | --- | --- | --- | --- | --- | --- |
| 517 | 1.4.1.1.3 | **Configuration and Release Management Approach & Plan** |  | 164d | 2022-11-01 A | 2023-06-16 A |  | 100% |  | 2022-11-01 | 2023-06-16 | 164d | 2022-11-01 | 2023-04-28 |  |  |  | N/A | N/A | M9 | 5.0 | N/A | Systems Integration Testing (SIT) |  |  |  |  |  |
| 518 | 1.4.1.1.3.1 | Develop document |  | 69d | 2022-11-01 A | 2023-06-16 A |  | 100% |  | 2022-11-01 | 2023-06-16 | 69d | 2022-11-01 | 2023-01-31 |  | start no earlier than 2022-11-01 |  | SI Test |  |  | 5.0 | Simon Berry | Systems Integration Testing (SIT) | Complete | COMPLETE |  |  |  |
| 519 | 1.4.1.1.3.2 | Review, update and agree Configuration and Release Management Approach & Plan internally |  | 63d | 2023-02-01 A | 2023-04-28 A | 518 | 100% |  | 2023-02-01 | 2023-04-28 | 63d | 2023-02-01 | 2023-04-28 |  |  |  | SRO Function | IPA,SI Test |  | 5.0 | Simon Berry | Systems Integration Testing (SIT) | Complete | COMPLETE |  |  |  |
| 520 | 1.4.1.1.4 | **Test Data Overarching Approach & Plan** |  | 179d | 2022-11-14 A | 2023-07-20 A |  | 100% |  | 2022-11-14 | 2023-07-20 | 179d | 2022-11-14 | 2023-05-18 |  |  |  | N/A | N/A | M9 | 5.0 | N/A | Systems Integration Testing (SIT) |  |  |  |  |  |
| 521 | 1.4.1.1.4.1 | Develop document |  | 20d | 2022-11-14 A | 2022-12-09 A |  | 100% |  | 2022-11-14 | 2022-12-09 | 20d | 2022-11-14 | 2022-12-09 |  | start no earlier than 2022-11-14 |  | SI Test | PP |  | 5.0 | Cesar Lopes | Systems Integration Testing (SIT) | Complete | COMPLETE |  |  |  |
| 522 | 1.4.1.1.4.2 | Document review and update |  | 155d | 2022-12-12 A | 2023-07-14 A | 521 | 100% |  | 2022-12-12 | 2023-07-14 | 155d | 2022-12-12 | 2023-05-17 |  |  |  | PP | SI Test,IPA |  | 5.0 | Cesar Lopes | Systems Integration Testing (SIT) | Complete | COMPLETE |  |  |  |
| 523 | 1.4.1.1.4.3 | Test Data Overarching Approach & Plan approved by TMAG | milestone | 0d | 2023-07-19 A | 2023-07-19 A | 522FS+3d | 100% |  | 2023-07-19 | 2023-07-19 | 0d | 2023-05-17 | 2023-05-17 |  |  |  | SRO Test | PP,IPA,Code Bodies |  | 5.0 | Cesar Lopes | Systems Integration Testing (SIT) | Complete | COMPLETE | T3-TE-0072 | SITAG | T3 |
| 524 | 1.4.1.1.4.4 | Document publication final version |  | 1d | 2023-07-20 A | 2023-07-20 A | 523 | 100% |  | 2023-07-20 | 2023-07-20 | 1d | 2023-05-18 | 2023-05-18 |  |  |  | SI Test |  |  | 5.0 | Cesar Lopes | Systems Integration Testing (SIT) | Complete | COMPLETE |  |  |  |
| 525 | 1.4.1.1.5 | **Interface Code of Connection (dates subject to DIP Service Provider's plan)** |  | 48d | 2023-03-01 A | 2023-05-05 A |  | 100% |  | 2023-03-01 | 2023-05-05 | 48d | 2023-03-01 | 2023-05-05 |  |  |  | N/A | N/A |  | 5.0 | N/A | Systems Integration Testing (SIT) |  |  |  |  |  |
| 526 | 1.4.1.1.5.1 | Develop Interface Code of Connection with DIP Service Provider |  | 43d | 2023-03-01 A | 2023-04-28 A |  | 100% |  | 2023-03-01 | 2023-04-28 | 43d | 2023-03-01 | 2023-04-28 |  | must start on 2023-03-01 |  | DIP Provider | SI Test |  | 5.0 |  | Systems Integration Testing (SIT) | Complete | COMPLETE |  |  |  |
| 527 | 1.4.1.1.5.2 | Interface Code of Connection approved at SDWG | milestone | 0d | 2023-05-05 A | 2023-05-05 A | 526FS+5d | 100% |  | 2023-05-05 | 2023-05-05 | 0d | 2023-05-05 | 2023-05-05 |  |  |  | SI Test | PP |  | 5.0 |  | Systems Integration Testing (SIT) | Complete | COMPLETE |  |  |  |
| 528 | 1.4.1.1.6 | **Test Traceability** |  | 165d | 2023-06-01 A | 2024-01-17 |  | 98% | 2.71d | 2023-06-01 | 2024-01-17 | 165d | 2023-06-01 | 2023-09-01 | 1026d |  | -0 | N/A | N/A |  | 5.0 | N/A | Systems Integration Testing (SIT) |  |  |  |  |  |
| 529 | 1.4.1.1.6.1 | RTM containing Method Statement Implied Requirements into Azure DevOps |  | 22d | 2023-06-01 A | 2023-06-30 A |  | 100% |  | 2023-06-01 | 2023-06-30 | 22d | 2023-06-01 | 2023-06-30 |  | must start on 2023-06-01 |  | SI Test |  |  | 5.0 |  | Systems Integration Testing (SIT) | Complete | COMPLETE |  |  |  |
| 530 | 1.4.1.1.6.2 | RTM Containing Interface Catalogue Implied Requirements |  | 27d | 2023-06-01 A | 2023-07-07 A |  | 100% |  | 2023-06-01 | 2023-07-07 | 27d | 2023-06-01 | 2023-07-07 |  | must start on 2023-06-01 |  | SI Test |  |  | 5.0 |  | Systems Integration Testing (SIT) | Complete | COMPLETE |  |  |  |
| 531 | 1.4.1.1.6.3 | SIT CIT Full Traceability & Coverage complete |  | 118d | 2023-07-10 A | 2023-12-20 A | 530, 529 | 100% |  | 2023-07-10 | 2023-12-20 | 110d | 2023-07-10 | 2023-07-28 |  |  |  | SI Test |  |  | 5.0 |  | Systems Integration Testing (SIT) | Complete | COMPLETE |  |  |  |
| 532 | 1.4.1.1.6.4 | SIT Functional Full Traceability & Coverage complete |  | 138d | 2023-07-10 A | 2024-01-17 | 530, 529 | 96% | 5d | 2023-07-10 | 2024-01-17 | 138d | 2023-07-10 | 2023-09-01 | 1026d |  |  | SI Test |  |  | 5.0 | Roger Robar | Systems Integration Testing (SIT) | Overdue | RED |  |  |  |
| 533 | 1.4.1.2 | **Test Tool Development** |  | 256d? | 2022-10-31 A | 2023-10-23 A |  | 100% |  | 2022-10-31 | 2023-10-23 | 175d | 2022-10-31 | 2023-06-30 |  |  |  | N/A | N/A |  | 5.0 | N/A | Systems Integration Testing (SIT) |  |  |  |  |  |
| 534 | 1.4.1.2.1 | **Test Management Tool** |  | 256d | 2022-10-31 A | 2023-10-23 A |  | 100% |  | 2022-10-31 | 2023-10-23 | 175d | 2022-10-31 | 2023-06-30 |  |  |  | N/A | N/A |  | 5.0 | N/A | Systems Integration Testing (SIT) |  |  |  |  |  |
| 535 | 1.4.1.2.1.1 | **Test Management Tool Implementation** |  | 256d | 2022-10-31 A | 2023-10-23 A |  | 100% |  | 2022-10-31 | 2023-10-23 | 175d | 2022-10-31 | 2023-06-30 |  |  |  | N/A | N/A |  | 5.0 | N/A | Systems Integration Testing (SIT) |  |  |  |  |  |
| 536 | 1.4.1.2.1.1.1 | Requirements identification |  | 40d | 2022-10-31 A | 2022-12-23 A |  | 100% |  | 2022-10-31 | 2022-12-23 | 40d | 2022-10-31 | 2022-12-23 |  |  |  | SI DevOps | SI Test |  | 5.0 | Simon Berry | Systems Integration Testing (SIT) | Complete | COMPLETE |  |  |  |
| 537 | 1.4.1.2.1.1.2 | Development |  | 125d | 2023-01-02 A | 2023-06-23 A | 536FS+5d | 100% |  | 2023-01-02 | 2023-06-23 | 125d | 2023-01-02 | 2023-06-23 |  |  |  | SI DevOps | SI Test |  | 5.0 | Simon Berry | Systems Integration Testing (SIT) | Complete | COMPLETE |  |  |  |
| 538 | 1.4.1.2.1.1.3 | Testing |  | 125d | 2023-01-02 A | 2023-06-23 A | 537FF | 100% |  | 2023-01-02 | 2023-06-23 | 125d | 2023-01-02 | 2023-06-23 |  |  |  | SI DevOps | SI Test |  | 5.0 | Simon Berry | Systems Integration Testing (SIT) | Complete | COMPLETE |  |  |  |
| 539 | 1.4.1.2.1.1.4 | Accept tool | milestone | 0d | 2023-06-23 A | 2023-06-23 A | 538FF | 100% |  | 2023-06-23 | 2023-06-23 | 0d | 2023-06-23 | 2023-06-23 |  |  |  | SI DevOps | SI Test |  | 5.0 | Simon Berry | Systems Integration Testing (SIT) | Complete | COMPLETE |  |  |  |
| 540 | 1.4.1.2.1.1.5 | Implementation |  | 1d | 2023-10-23 A | 2023-10-23 A | 539FS+85d | 100% |  | 2023-10-23 | 2023-10-23 | 1d | 2023-06-30 | 2023-06-30 |  |  |  | SI DevOps | PPC |  | 5.0 | Simon Berry | Systems Integration Testing (SIT) | Complete | COMPLETE |  |  |  |

Notes:
- 517: Action: 1280 DIP available for Onboarding (need to add a link - non sit ldso)
- 532: Stays red till delivery plan agreed at SITAG

| ID | WBS | Task | Duration | Start | Finish | Predecessors | Complete | Baseline start | Baseline finish | Baseline duration | Baseline 1 start | Baseline 1 finish | Constraint | Responsible | Involved | Update Version | MHHS Resource Name | MHHS Programme Phase | Sched Status | RAG | Task Status |
| --- | --- | --- | --- | --- | --- | --- | --- | --- | --- | --- | --- | --- | --- | --- | --- | --- | --- | --- | --- | --- | --- |
| 541 | 1.4.1.2.1.2 | **Test Management Tool User Guide** | 115d | 2023-01-02 A | 2023-06-09 A |  | 100% | 2023-01-02 | 2023-06-09 | 115d | 2023-01-02 | 2023-06-09 |  | N/A | N/A | 5.0 | N/A | Systems Integration Testing (SIT) |  |  |  |
| 542 | 1.4.1.2.1.2.1 | Develop document | 100d | 2023-01-02 A | 2023-05-19 A | 537SS, 538SS | 100% | 2023-01-02 | 2023-05-19 | 100d | 2023-01-02 | 2023-05-19 | start no earlier than 2023-01-02 | SI DevOps |  | 5.0 |  | Systems Integration Testing (SIT) | Complete | COMPLETE |  |
| 543 | 1.4.1.2.1.2.2 | Review, update and agree Test Management Tool User Guide internally | 15d | 2023-05-22 A | 2023-06-09 A | 542 | 100% | 2023-05-22 | 2023-06-09 | 15d | 2023-05-22 | 2023-06-09 |  | SRO Function | SI DevOps,SI Test,IPA,PPC | 5.0 |  | Systems Integration Testing (SIT) | Complete | COMPLETE |  |
| 544 | 1.4.1.2.1.3 | **Test Management Tool Configuration Guide** | 60d | 2023-01-02 A | 2023-03-24 A |  | 100% | 2023-01-02 | 2023-03-24 | 60d | 2023-01-02 | 2023-03-24 |  | N/A | N/A | 5.0 | N/A | Systems Integration Testing (SIT) |  |  |  |
| 545 | 1.4.1.2.1.3.1 | Develop document | 45d | 2023-01-02 A | 2023-03-03 A | 536 | 100% | 2023-01-02 | 2023-03-03 | 45d | 2023-01-02 | 2023-03-03 | start no earlier than 2023-01-02 | SI DevOps | SI Test,IPA | 5.0 |  | Systems Integration Testing (SIT) | Complete | COMPLETE |  |
| 546 | 1.4.1.2.1.3.2 | Review, update and agree Test Management Tool Configuration Guide internally | 15d | 2023-03-06 A | 2023-03-24 A | 545 | 100% | 2023-03-06 | 2023-03-24 | 15d | 2023-03-06 | 2023-03-24 |  | SRO Function | SI DevOps,SI Test,IPA | 5.0 |  | Systems Integration Testing (SIT) | Complete | COMPLETE |  |
| 547 | 1.4.1.2.2 | **Secure Volunteer SIT Participants** | 163d? | 2023-01-31 A | 2023-09-14 A |  | 100% | 2023-01-31 | 2023-09-14 | 0d |  |  |  |  |  | 6.0 |  |  | Overdue Start |  | -680.67 |
| 548 | 1.4.1.2.2.1 | PPs decide whether to volunteer to participate in SIT and inform Programme of decision via Round 3 Replan consultation | 1d? | 2023-01-31 A | 2023-01-31 A |  | 100% | 2023-01-31 | 2023-01-31 | 0d |  |  | finish no earlier than 2023-01-31 | SI Test |  | 6.0 |  |  | Complete | COMPLETE |  |
| 549 | 1.4.1.2.2.2 | Assurance of SIT volunteers' plans (submitted via Round 3 Replan Consultation) | 1d? | 2023-02-14 A | 2023-02-14 A |  | 100% | 2023-02-14 | 2023-02-14 | 0d |  |  | finish no earlier than 2023-02-14 | SI Test |  | 6.0 |  |  | Complete | COMPLETE |  |
| 550 | 1.4.1.2.2.3 | SIT Participant Volunteers Identified | 1d? | 2023-02-14 A | 2023-02-14 A |  | 100% | 2023-02-14 | 2023-02-14 | 0d |  |  | start no earlier than 2023-02-14 | SI Test |  | 6.0 |  |  | Complete | COMPLETE |  |
| 551 | 1.4.1.2.2.4 | Engagement with SIT volunteers | 1d? | 2023-05-23 A | 2023-05-23 A |  | 100% | 2023-05-23 | 2023-05-23 | 0d |  |  | finish no earlier than 2023-05-23 | SI Test |  | 6.0 |  |  | Complete | COMPLETE |  |
| 552 | 1.4.1.2.2.5 | SIT Participants Agreed | 1d? | 2023-05-23 A | 2023-05-23 A |  | 100% | 2023-05-23 | 2023-05-23 | 0d |  |  | start no earlier than 2023-05-23 | SI Test |  | 6.0 |  |  | Complete | COMPLETE |  |
| 553 | 1.4.1.2.2.6 | **Data Protection Impact Assessment (DPIA)** | 11d? | 2023-06-30 A | 2023-07-14 A |  | 100% | 2023-06-30 | 2023-07-14 | 0d |  |  |  | SI Test |  | 6.0 |  |  | Overdue Start |  | -680.67 |
| 554 | 1.4.1.2.2.6.1 | Conduct DPIA on Overall Test Data Approach | 1d? | 2023-06-30 A | 2023-06-30 A |  | 100% | 2023-06-30 | 2023-06-30 | 0d |  |  | finish no earlier than 2023-06-30 | SI Test |  | 6.0 |  |  | Complete | COMPLETE |  |
| 555 | 1.4.1.2.2.6.2 | Revise Overarching Test Data Approach& plan for DPIA (if required), including engagement with DWG | 1d? | 2023-07-13 A | 2023-07-13 A |  | 100% | 2023-07-13 | 2023-07-13 | 0d |  |  | finish no earlier than 2023-07-13 | SI Test |  | 6.0 |  |  | Complete | COMPLETE |  |
| 556 | 1.4.1.2.2.6.3 | Review (internal), update and approve revised Overarching Test Data Approach& Plan (if required) | 1d? | 2023-07-14 A | 2023-07-14 A |  | 100% | 2023-07-14 | 2023-07-14 | 0d |  |  | start no earlier than 2023-07-14 | SI Test |  | 6.0 |  |  | Complete | COMPLETE |  |
| 557 | 1.4.1.2.2.7 | **Data Sharing Agreements** | 30d? | 2023-08-04 A | 2023-09-14 A |  | 100% | 2023-08-04 | 2023-09-14 | 0d |  |  |  | SI Test |  | 6.0 |  |  | Overdue Start | COMPLETE | -680.67 |
| 558 | 1.4.1.2.2.7.1 | Produce Data Sharing Agreement for Industry Review | 1d? | 2023-08-04 A | 2023-08-04 A |  | 100% | 2023-08-04 | 2023-08-04 | 0d |  |  | finish no earlier than 2023-08-04 | SI Test |  | 6.0 |  |  | Complete | COMPLETE |  |
| 559 | 1.4.1.2.2.7.2 | Manage Participant Queries and Contract Agreement Execution | 1d? | 2023-09-14 A | 2023-09-14 A |  | 100% | 2023-09-14 | 2023-09-14 | 0d |  |  | finish no earlier than 2023-09-14 | SI Test |  | 6.0 |  |  | Complete | COMPLETE |  |
| 560 | 1.4.1.2.2.7.3 | Data Sharing Agreements Complete | 1d? | 2023-09-14 A | 2023-09-14 A |  | 100% | 2023-09-14 | 2023-09-14 | 0d |  |  | start no earlier than 2023-09-14 | SI Test |  | 6.0 |  |  | Complete | COMPLETE |  |
| 561 | 1.4.1.2.2.8 | **Production Data Cut & Data Obfuscation** | 55d? | 2023-06-19 A | 2023-09-01 A |  | 100% | 2023-06-19 | 2023-09-01 | 0d |  |  |  |  |  | 6.0 |  |  | Overdue Start | COMPLETE | -680.67 |
| 562 | 1.4.1.2.2.8.1 | **SI Data Cut Preparation& Infrastructure** | 45d? | 2023-06-19 A | 2023-08-18 A |  | 100% | 2023-06-19 | 2023-08-18 | 0d |  |  |  |  |  | 6.0 |  |  | Overdue Start | COMPLETE | -680.67 |
| 563 | 1.4.1.2.2.8.1.1 | SI Data Cut Planning activities (incl. pre-cut and post-cut cleansing and population approach) | 1d? | 2023-06-19 A | 2023-06-19 A |  | 100% | 2023-06-19 | 2023-06-19 | 0d |  |  | finish no earlier than 2023-06-19 |  |  | 6.0 |  |  | Complete | COMPLETE |  |
| 564 | 1.4.1.2.2.8.1.2 | Set up SI database and transmission structure | 1d? | 2023-08-17 A | 2023-08-17 A |  | 100% | 2023-08-17 | 2023-08-17 | 0d |  |  | finish no earlier than 2023-08-17 |  |  | 6.0 |  |  | Complete | COMPLETE |  |
| 565 | 1.4.1.2.2.8.1.3 | Mechanism for transfer of data in place | 1d? | 2023-08-18 A | 2023-08-18 A |  | 100% | 2023-08-18 | 2023-08-18 | 0d |  |  | start no earlier than 2023-08-18 |  |  | 6.0 |  |  | Complete | COMPLETE |  |
| 566 | 1.4.1.2.2.8.1.4 | SI Data Cut Preparation& Infrastructure Complete | 1d? | 2023-08-18 A | 2023-08-18 A |  | 100% | 2023-08-18 | 2023-08-18 | 0d |  |  | start no earlier than 2023-08-18 |  |  | 6.0 |  |  | Complete | COMPLETE |  |

| ID | WBS | Task | Type | Duration | Start | Finish | Predecessors | Complete | Remaining | Baseline start | Baseline finish | Baseline duration | Baseline 1 start | Baseline 1 finish | Total slack | Constraint | Baseline cost | Task Status | Update Version | Sched Status | RAG | Responsible | Involved | MHHS Resource Name | MHHS Programme Phase | Milestone ID | Text29 | Tier | Artefact ID |
| --- | --- | --- | --- | --- | --- | --- | --- | --- | --- | --- | --- | --- | --- | --- | --- | --- | --- | --- | --- | --- | --- | --- | --- | --- | --- | --- | --- | --- | --- |
| 567 | 1.4.1.2.2.8.2 | **Production Data Cut** |  | 55d? | 2023-06-19 A | 2023-09-01 A |  | 100% |  | 2023-06-19 | 2023-09-01 | 0d |  |  |  |  |  | -680.67 | 6.0 | Overdue Start | COMPLETE |  |  |  |  |  |  |  |  |
| 568 | 1.4.1.2.2.8.2.1 | Notification of Production Data Cut issued to relevant participants |  | 1d? | 2023-06-19 A | 2023-06-19 A |  | 100% |  | 2023-06-19 | 2023-06-19 | 0d |  |  |  | start no earlier than 2023-06-19 |  |  | 6.0 | Complete | COMPLETE |  |  |  |  |  |  |  |  |
| 569 | 1.4.1.2.2.8.2.2 | Coordinate relevant participants taking data cut from production systems |  | 1d? | 2023-08-11 A | 2023-08-11 A |  | 100% |  | 2023-08-11 | 2023-08-11 | 0d |  |  |  | finish no earlier than 2023-08-11 |  |  | 6.0 | Complete | COMPLETE |  |  |  |  |  |  |  |  |
| 570 | 1.4.1.2.2.8.2.3 | Production data cut GONG decision |  | 1d? | 2023-08-16 A | 2023-08-16 A |  | 100% |  | 2023-08-16 | 2023-08-16 | 0d |  |  |  | start no earlier than 2023-08-16 |  |  | 6.0 | Complete | COMPLETE |  |  |  |  |  |  |  |  |
| 571 | 1.4.1.2.2.8.2.4 | Relevant participants take data cut from production systems (Saturday 19 August) |  | 1d? | 2023-08-21 A | 2023-08-21 A |  | 100% |  | 2023-08-21 | 2023-08-21 | 0d |  |  |  | start no earlier than 2023-08-21 |  |  | 6.0 | Complete | COMPLETE |  |  |  |  |  |  |  |  |
| 572 | 1.4.1.2.2.8.2.5 | EES transmit request data to SI |  | 1d? | 2023-08-25 A | 2023-08-25 A |  | 100% |  | 2023-08-25 | 2023-08-25 | 0d |  |  |  | finish no earlier than 2023-08-25 |  |  | 6.0 | Complete | COMPLETE |  |  |  |  |  |  |  |  |
| 573 | 1.4.1.2.2.8.2.6 | Check data alignment and integrity of data cut |  | 1d? | 2023-09-01 A | 2023-09-01 A |  | 100% |  | 2023-09-01 | 2023-09-01 | 0d |  |  |  | finish no earlier than 2023-09-01 |  |  | 6.0 | Complete | COMPLETE |  |  |  |  |  |  |  |  |
| 574 | 1.4.1.2.2.8.2.7 | Data cut from relevant participants' production systems completed (Saturday 19 August) |  | 1d? | 2023-08-21 A | 2023-08-21 A |  | 100% |  | 2023-08-21 | 2023-08-21 | 0d |  |  |  | start no earlier than 2023-08-21 |  |  | 6.0 | Complete | COMPLETE |  |  |  |  |  |  |  |  |
| 575 | 1.4.1.2.2.8.2.8 | Production Data Cut Complete |  | 1d? | 2023-08-21 A | 2023-08-21 A |  | 100% |  | 2023-08-21 | 2023-08-21 | 0d |  |  |  | start no earlier than 2023-08-21 |  |  | 6.0 | Complete | COMPLETE |  |  |  |  |  |  |  |  |
| 576 | 1.4.1.3 | **SIT Participation** |  | 147d | 2022-10-31 A | 2023-05-23 A |  | 100% |  | 2022-10-31 | 2023-05-23 | 147d | 2022-10-31 | 2023-05-23 |  |  |  |  | 5.0 |  |  | N/A | N/A | N/A | Systems Integration Testing (SIT) |  |  |  |  |
| 577 | 1.4.1.3.1 | PPs decide whether to volunteer to participate in SIT and inform Programme of decision via Round 3 Replan consultation |  | 67d | 2022-10-31 A | 2023-01-31 A | 34FF | 100% |  | 2022-10-31 | 2023-01-31 | 67d | 2022-10-31 | 2023-01-31 |  |  |  |  | 5.0 | Complete | COMPLETE | PP | SI Test,PMO |  | Systems Integration Testing (SIT) |  |  |  |  |
| 578 | 1.4.1.3.2 | Assurance of SIT volunteers' plans (submitted via Round 3 Replan Consultation) |  | 10d | 2023-02-01 A | 2023-02-14 A | 577, 34 | 100% |  | 2023-02-01 | 2023-02-14 | 10d | 2023-02-01 | 2023-02-14 |  |  |  |  | 5.0 | Complete | COMPLETE | SI Test | PP |  | Systems Integration Testing (SIT) |  |  |  |  |
| 579 | 1.4.1.3.3 | SIT Participant Volunteers Identified | milestone | 0d | 2023-02-14 A | 2023-02-14 A | 578FF | 100% |  | 2023-02-14 | 2023-02-14 | 0d | 2023-02-14 | 2023-02-14 |  |  |  |  | 5.0 | Complete | COMPLETE | SI Test | PP |  | Systems Integration Testing (SIT) | T2-TE-0100 | SITAG | T2 |  |
| 580 | 1.4.1.3.4 | Engagement with SIT volunteers |  | 147d | 2022-10-31 A | 2023-05-23 A |  | 100% |  | 2022-10-31 | 2023-05-23 | 147d | 2022-10-31 | 2023-05-23 |  |  |  |  | 5.0 | Complete | COMPLETE | SI Test | PP |  | Systems Integration Testing (SIT) |  |  |  |  |
| 581 | 1.4.1.3.5 | SIT Participants Agreed | milestone | 0d | 2023-05-23 A | 2023-05-23 A | 580, 615FS-74d | 100% |  | 2023-05-23 | 2023-05-23 | 0d | 2023-05-23 | 2023-05-23 |  |  |  |  | 5.0 | Complete | COMPLETE | SI Test | PP |  | Systems Integration Testing (SIT) | T2-TE-0150 | SITAG | T2 |  |
| 582 | 1.4.1.4 | **SIT Stage-Specific Preparation** |  | 665d? | 2022-10-31 A | 2025-05-16 |  | 77% | 154.6d? | 2022-10-31 | 2025-05-16 | 611d | 2022-10-31 | 2025-03-10 | 679d |  | -0 |  | 5.0 |  |  | N/A | N/A | N/A | Systems Integration Testing (SIT) |  |  |  |  |
| 583 | 1.4.1.4.1 | **SIT Component Integration Preparation** |  | 320d | 2022-10-31 A | 2024-01-19 A |  | 100% |  | 2022-10-31 | 2024-01-19 | 321d | 2022-10-31 | 2024-01-22 |  |  | -0 |  | 5.0 |  |  | N/A | N/A | N/A | Systems Integration Testing (SIT) |  |  |  |  |
| 584 | 1.4.1.4.1.1 | **Test Approach & Plan** |  | 188d | 2022-10-31 A | 2023-07-19 A |  | 100% |  | 2022-10-31 | 2023-07-19 | 188d | 2022-10-31 | 2023-07-19 |  |  |  |  | 5.0 |  |  | N/A | N/A | N/A | Systems Integration Testing (SIT) |  |  |  |  |
| 585 | 1.4.1.4.1.1.1 | Develop document with SITWG |  | 159d | 2022-10-31 A | 2023-06-08 A |  | 100% |  | 2022-10-31 | 2023-06-08 | 159d | 2022-10-31 | 2023-05-12 |  |  |  |  | 5.0 | Complete | COMPLETE | SI Test |  |  | Systems Integration Testing (SIT) |  |  |  |  |
| 586 | 1.4.1.4.1.1.2 | Industry consultation |  | 10d | 2023-06-09 A | 2023-06-22 A | 585 | 100% |  | 2023-06-09 | 2023-06-22 | 10d |  |  |  |  |  |  | 5.1 | Complete | COMPLETE | PP |  |  | Systems Integration Testing (SIT) |  |  |  |  |
| 587 | 1.4.1.4.1.1.3 | Artefact review (via TMAG) and updates |  | 19d | 2023-06-23 A | 2023-07-19 A | 586 | 100% |  | 2023-06-23 | 2023-07-19 | 19d | 2023-06-09 | 2023-07-06 |  | finish no earlier than 2023-07-06 |  |  | 5.0 | Complete | COMPLETE | SI Test | PP,IPA,Code Bodies |  | Systems Integration Testing (SIT) |  |  |  |  |
| 588 | 1.4.1.4.1.1.4 | SIT Component Integration Testing Test Approach & Plan approved | milestone | 0d | 2023-07-19 A | 2023-07-19 A | 587 | 100% |  | 2023-07-19 | 2023-07-19 | 0d | 2023-07-19 | 2023-07-19 |  | finish no earlier than 2023-07-19 |  |  | 5.0 | Complete | COMPLETE | SI Test | PP |  | Systems Integration Testing (SIT) | T3-TE-0012 | SITAG | T3 | MHHS-ART073 |
| 589 | 1.4.1.4.1.2 | **Test Data Approach & Plan** |  | 29d | 2023-06-09 A | 2023-07-19 A |  | 100% |  | 2023-06-09 | 2023-07-19 | 29d | 2023-06-09 | 2023-07-19 |  |  |  |  | 5.0 |  |  | N/A | N/A | N/A | Systems Integration Testing (SIT) |  |  |  |  |
| 590 | 1.4.1.4.1.2.1 | Industry consultation |  | 10d | 2023-06-09 A | 2023-06-22 A | 586SS | 100% |  | 2023-06-09 | 2023-06-22 | 10d |  |  |  |  |  |  | 5.1 | Complete | COMPLETE | PP |  | Cesar Lopes | Systems Integration Testing (SIT) |  |  |  |  |
| 591 | 1.4.1.4.1.2.2 | Artefact review (via TMAG) and updates |  | 19d | 2023-06-23 A | 2023-07-19 A | 590 | 100% |  | 2023-06-23 | 2023-07-19 | 19d | 2023-06-09 | 2023-07-06 |  |  |  |  | 5.0 | Complete | COMPLETE | SI Test | PP | Cesar Lopes | Systems Integration Testing (SIT) |  |  |  |  |
| 592 | 1.4.1.4.1.2.3 | SIT Component Integration Testing Test Data Approach & Plan approved | milestone | 0d | 2023-07-19 A | 2023-07-19 A | 591 | 100% |  | 2023-07-19 | 2023-07-19 | 0d | 2023-07-19 | 2023-07-19 |  |  |  |  | 5.0 | Complete | COMPLETE | SI Test | IPA | Cesar Lopes | Systems Integration Testing (SIT) |  |  |  |  |

| ID | WBS | Task | Type | Duration | Start | Finish | Predecessors | Complete | Baseline start | Baseline finish | Baseline duration | Baseline 1 start | Baseline 1 finish | Constraint | Baseline cost | Responsible | Involved | Update Version | MHHS Resource Name | MHHS Programme Phase | Sched Status | RAG | Artefact ID | Milestone ID | Text29 | Tier | Task Status |
| --- | --- | --- | --- | --- | --- | --- | --- | --- | --- | --- | --- | --- | --- | --- | --- | --- | --- | --- | --- | --- | --- | --- | --- | --- | --- | --- | --- |
| 593 | 1.4.1.4.1.3 | **Test scenarios** |  | 173d | 2023-01-02 A | 2023-08-30 A |  | 100% | 2023-01-02 | 2023-08-30 | 173d | 2023-01-02 | 2023-06-02 |  |  | N/A | N/A | 5.0 | N/A | Systems Integration Testing (SIT) |  |  |  |  |  |  |  |
| 594 | 1.4.1.4.1.3.1 | Development of test scenarios | milestone | 0d | 2023-01-02 A | 2023-04-28 A | 585SS+45d | 100% | 2023-01-02 | 2023-04-28 | 85d | 2023-01-02 | 2023-04-28 |  |  | SI Test | PP, Code Bodies | 5.0 |  | Systems Integration Testing (SIT) | Complete | COMPLETE |  |  |  |  |  |
| 595 | 1.4.1.4.1.3.2 | Review test scenarios with SIT Working Group |  | 11d | 2023-02-01 A | 2023-08-09 A | 594SS+22d | 100% | 2023-02-01 | 2023-08-09 | 136d | 2023-02-01 | 2023-05-26 |  |  | SI Test | PP, Code Bodies, IPA | 5.0 |  | Systems Integration Testing (SIT) | Complete | COMPLETE |  |  |  |  |  |
| 596 | 1.4.1.4.1.3.3 | SIT Component Integration Testing Test scenarios approved | milestone | 0d | 2023-08-30 A | 2023-08-30 A | 595FS+15d | 100% | 2023-08-30 | 2023-08-30 | 0d | 2023-06-02 | 2023-06-02 |  |  | SI Test | PP | 5.6 |  | Systems Integration Testing (SIT) | Complete | COMPLETE | MHHS-ART148 | T3-TE-0014 | SITAG | T3 |  |
| 597 | 1.4.1.4.1.4 | **Test cases** |  | 160d | 2023-05-01 A | 2023-12-08 A |  | 100% | 2023-05-01 | 2023-12-08 | 160d | 2023-05-01 | 2023-09-01 |  |  | N/A | N/A | 5.6 | N/A | Systems Integration Testing (SIT) |  |  |  |  |  |  |  |
| 598 | 1.4.1.4.1.4.1 | **SI Test cases** |  | 160d | 2023-05-01 A | 2023-12-08 A |  | 100% | 2023-05-01 | 2023-12-08 | 160d | 2023-05-01 | 2023-09-01 |  |  | N/A | N/A | 5.6 | N/A | Systems Integration Testing (SIT) |  |  |  |  |  |  |  |
| 599 | 1.4.1.4.1.4.1.1 | **Batch 1 (CIT Intervals 1 and 2)** |  | 110d | 2023-05-01 A | 2023-09-29 A |  | 100% | 2023-05-01 | 2023-09-29 | 110d |  |  |  |  | N/A | N/A | 5.6 | N/A | Systems Integration Testing (SIT) |  |  |  |  |  |  | -290.67 |
| 600 | 1.4.1.4.1.4.1.1.1 | Develop Test cases |  | 100d | 2023-05-01 A | 2023-09-15 A | 594 | 100% | 2023-05-01 | 2023-09-15 | 100d | 2023-05-01 | 2023-07-28 |  |  | SI Test |  | 5.6 |  | Systems Integration Testing (SIT) | Complete | COMPLETE |  |  |  |  |  |
| 601 | 1.4.1.4.1.4.1.1.2 | Review Test cases with SIT Working Group |  | 9d | 2023-09-18 A | 2023-09-28 A | 600 | 100% | 2023-09-18 | 2023-09-28 | 9d | 2023-05-26 | 2023-08-25 |  |  | SI Test | PP,IPA | 5.6 |  | Systems Integration Testing (SIT) | Complete | COMPLETE |  |  |  |  |  |
| 602 | 1.4.1.4.1.4.1.1.3 | SIT Component Integration Testing Test cases Batch 1 (CIT Intervals 1 and 2) approved at ETMAG | milestone | 0d | 2023-09-29 A | 2023-09-29 A | 601FS+1d | 100% | 2023-09-29 | 2023-09-29 | 0d | 2023-09-01 | 2023-09-01 |  |  | SI Test | PP | 5.6 |  | Systems Integration Testing (SIT) | Complete | COMPLETE | MHHS-ART073 | T3-TE-0069 | SITAG | T3 |  |
| 603 | 1.4.1.4.1.4.1.2 | **Batch 2 (CIT Intervals 3 and 4)** |  | 25d | 2023-10-02 A | 2023-11-03 A |  | 100% | 2023-10-02 | 2023-11-03 | 25d |  |  |  |  | N/A | N/A | 5.6 | N/A | Systems Integration Testing (SIT) |  |  |  |  |  |  | -290.67 |
| 604 | 1.4.1.4.1.4.1.2.1 | Develop Test cases |  | 15d | 2023-10-02 A | 2023-10-20 A | 602 | 100% | 2023-10-02 | 2023-10-20 | 15d | 2023-05-01 | 2023-07-28 |  |  | SI Test |  | 5.6 |  | Systems Integration Testing (SIT) | Complete | COMPLETE |  |  |  |  |  |
| 605 | 1.4.1.4.1.4.1.2.2 | Review Test cases with SIT Working Group |  | 9d | 2023-10-23 A | 2023-11-02 A | 604 | 100% | 2023-10-23 | 2023-11-02 | 9d | 2023-05-26 | 2023-08-25 |  |  | SI Test | PP,IPA | 5.6 |  | Systems Integration Testing (SIT) | Complete | COMPLETE |  |  |  |  |  |
| 606 | 1.4.1.4.1.4.1.2.3 | SIT Component Integration Testing Test cases Batch 2 (CIT Intervals 3 and 4) approved at ETMAG | milestone | 0d | 2023-11-03 A | 2023-11-03 A | 605FS+1d | 100% | 2023-11-03 | 2023-11-03 | 0d | 2023-09-01 | 2023-09-01 |  |  | SI Test | PP | 5.11 |  | Systems Integration Testing (SIT) | Complete | COMPLETE |  | T3-TE-0104 | SITAG | T3 |  |
| 607 | 1.4.1.4.1.4.1.3 | **Batch 3 (CIT Intervals 5 and 6)** |  | 25d | 2023-11-03 A | 2023-12-08 A |  | 100% | 2023-11-03 | 2023-12-08 | 25d |  |  |  |  | N/A | N/A | 5.6 | N/A | Systems Integration Testing (SIT) |  |  |  |  |  |  | -290.67 |
| 608 | 1.4.1.4.1.4.1.3.1 | Develop Test cases |  | 15d | 2023-11-03 A | 2023-11-24 A | 606 | 100% | 2023-11-03 | 2023-11-24 | 15d | 2023-05-01 | 2023-07-28 |  |  | SI Test |  | 5.6 |  | Systems Integration Testing (SIT) | Complete | COMPLETE |  |  |  |  |  |
| 609 | 1.4.1.4.1.4.1.3.2 | Review Test cases with SIT Working Group |  | 9d | 2023-11-27 A | 2023-12-07 A | 608 | 100% | 2023-11-27 | 2023-12-07 | 9d | 2023-05-26 | 2023-08-25 |  |  | SI Test | PP,IPA | 5.6 |  | Systems Integration Testing (SIT) | Complete | COMPLETE |  |  |  |  |  |
| 610 | 1.4.1.4.1.4.1.3.3 | SIT Component Integration Testing Test cases Batch 3 (CIT Intervals 5 and 6) approved at ETMAG | milestone | 0d | 2023-12-08 A | 2023-12-08 A | 609FS+1d | 100% | 2023-12-08 | 2023-12-08 | 0d | 2023-09-01 | 2023-09-01 |  |  | SI Test | PP | 5.14 |  | Systems Integration Testing (SIT) | Complete | COMPLETE |  | T3-TE-0105 | SITAG | T3 |  |
| 611 | 1.4.1.4.1.5 | **CIT Interval 1 Preparation** |  | 283d | 2022-11-16 A | 2023-12-15 A |  | 100% | 2022-11-16 | 2023-12-15 | 278d | 2022-11-16 | 2023-10-23 |  | -0 | N/A | N/A | 5.6 | N/A | Systems Integration Testing (SIT) |  |  |  |  |  |  |  |
| 612 | 1.4.1.4.1.5.1 | **Environments (SIT A)** |  | 246d | 2022-11-16 A | 2023-10-25 A |  | 100% | 2022-11-16 | 2023-10-25 | 239d | 2022-11-16 | 2023-10-06 |  |  | N/A | N/A | 5.0 | N/A | Systems Integration Testing (SIT) |  |  |  |  |  |  |  |
| 613 | 1.4.1.4.1.5.1.1 | PPs register PKI Officers and request PKI certificates |  | 5d | 2023-10-09 A | 2023-10-13 A |  | 100% | 2023-10-09 | 2023-10-13 | 5d | 2023-08-28 | 2023-09-01 | start no earlier than 2023-10-09 |  | PP | DIP Provider | 5.5 | Simon Berry | Systems Integration Testing (SIT) | Complete | COMPLETE |  |  |  |  |  |
| 614 | 1.4.1.4.1.5.1.2 | PPs register PKI Officers and request PKI certificates Complete - Interval 1 | milestone | 0d | 2023-10-25 A | 2023-10-25 A | 613FS+8d | 100% | 2023-10-25 | 2023-10-25 | 0d |  |  |  |  | PP | DIP Provider | 5.10 | Simon Berry | Systems Integration Testing (SIT) | Complete | COMPLETE |  | T3-TE-0094 | SITAG | T3 |  |
| 615 | 1.4.1.4.1.5.1.3 | PP SIT A environment preparation (incl. security certificates and security compliance) |  | 238d | 2022-11-16 A | 2023-10-13 A | 504 | 100% | 2022-11-16 | 2023-10-13 | 208d | 2022-11-16 | 2023-09-01 |  |  | PP | SI Test | 5.8 | Simon Berry | Systems Integration Testing (SIT) | Complete | COMPLETE |  |  |  |  |  |
| 616 | 1.4.1.4.1.5.1.4 | SI coordinate SIT Participants' SIT A environment preparation |  | 238d | 2022-11-16 A | 2023-10-13 A | 615SS | 100% | 2022-11-16 | 2023-10-13 | 208d | 2022-11-16 | 2023-09-01 |  |  | SI Test | PP | 5.8 | Simon Berry | Systems Integration Testing (SIT) | Complete | COMPLETE |  |  |  |  |  |
| 617 | 1.4.1.4.1.5.1.5 | PP submit self-declaration of environment preparation complete (incl. security certificates and security compliance) to Programme for assurance | milestone | 0d | 2023-10-13 A | 2023-10-13 A | 615FF | 100% | 2023-10-13 | 2023-10-13 | 0d | 2023-09-01 | 2023-09-01 | start no earlier than 2023-10-13 |  | PP | SI Test | 5.8 | Simon Berry | Systems Integration Testing (SIT) | Complete | COMPLETE |  |  |  |  |  |
| 618 | 1.4.1.4.1.5.1.6 | SI assure PPs' self-declaration of environment preparation complete (incl. security certificates and security compliance) |  | 5d | 2023-10-16 A | 2023-10-20 A | 617FF+5d | 100% | 2023-10-16 | 2023-10-20 | 5d | 2023-09-04 | 2023-09-08 |  |  | SI Test | PP | 5.8 | Simon Berry | Systems Integration Testing (SIT) | Complete | COMPLETE |  |  |  |  |  |
| 619 | 1.4.1.4.1.5.1.7 | SIT Participants' SIT A environments ready to start connectivity proving CIT Interval 1 | milestone | 0d | 2023-09-01 A | 2023-09-01 A | 617SS | 100% | 2023-09-01 | 2023-09-01 | 0d | 2023-09-01 | 2023-09-01 |  |  | PP | PP,IPA | 5.6 | Simon Berry | Systems Integration Testing (SIT) | Complete | COMPLETE | MHHS-ART139 | T3-TE-0019 | SITAG | T3 |  |
| 620 | 1.4.1.4.1.5.1.8 | PP SIT A environment connectivity proving |  | 10d | 2023-09-04 A | 2023-09-15 A | 619 | 100% | 2023-09-04 | 2023-09-15 | 20d | 2023-09-04 | 2023-09-29 |  |  | PP | SI Test | 5.8 | Simon Berry | Systems Integration Testing (SIT) | Complete | COMPLETE |  |  |  |  |  |
| 621 | 1.4.1.4.1.5.1.9 | SI coordinate SIT Participants' SIT A environment connectivity proving |  | 10d | 2023-09-04 A | 2023-09-15 A | 620SS | 100% | 2023-09-04 | 2023-09-15 | 20d | 2023-09-04 | 2023-09-29 |  |  | SI Test | PP | 5.8 | Simon Berry | Systems Integration Testing (SIT) | Complete | COMPLETE |  |  |  |  |  |
| 622 | 1.4.1.4.1.5.1.10 | PP deployment of MHHS solution code to SIT A environments |  | 10d | 2023-09-25 A | 2023-10-06 A | 663FF | 100% | 2023-09-25 | 2023-10-06 | 10d | 2023-09-18 | 2023-09-29 |  |  | PP | SI Test | 5.0 | Simon Berry | Systems Integration Testing (SIT) | Complete | COMPLETE |  |  |  |  |  |
| 623 | 1.4.1.4.1.5.1.11 | SI coordinate deployment of MHHS solution code to SIT Participants' SIT A environments |  | 10d | 2023-09-25 A | 2023-10-06 A | 663FF | 100% | 2023-09-25 | 2023-10-06 | 10d | 2023-09-18 | 2023-09-29 |  |  | SI Test | PP | 5.0 | Simon Berry | Systems Integration Testing (SIT) | Complete | COMPLETE |  |  |  |  |  |
| 624 | 1.4.1.4.1.5.1.12 | PP submit evidence of SIT A environment connectivity proving and code deployment completion to Programme for assurance |  | 30d | 2023-09-04 A | 2023-10-13 A | 620SS | 100% | 2023-09-04 | 2023-10-13 | 20d | 2023-09-04 | 2023-09-29 |  |  | PP | SI Test | 5.8 | Simon Berry | Systems Integration Testing (SIT) | Complete | COMPLETE |  |  |  |  |  |
| 625 | 1.4.1.4.1.5.1.13 | SI assurance of SIT Participants' SIT A environment connectivity proving and code deployment completion |  | 25d | 2023-09-18 A | 2023-10-20 A | 624FF+5d | 100% | 2023-09-18 | 2023-10-20 | 25d | 2023-09-04 | 2023-10-06 |  |  | SI Test | PP | 5.8 | Simon Berry | Systems Integration Testing (SIT) | Complete | COMPLETE |  |  |  |  |  |

Notes:
- 596: 17/8 - to go to ETMAG on 30/8
- 597: 18/8 - added in with LC to reflect his ppt slide
- 598: 18/8 - added in with LC to reflect his ppt slide
- 599: 18/8 - added in with LC to reflect his ppt slide
- 600: 18/8 - added in with LC to reflect his ppt slide
- 601: 18/8 - added in with LC to reflect his ppt slide
- 602: 18/8 - added in with LC to reflect his ppt slide / Guidance: 18/8 - needs to finish on 29/9 for ETWAG / Action: 18/8 - needs to finish on 29/9 for ETWAG. Update Milestone register after approval
- 603: 18/8 - added in with LC to reflect his ppt slide
- 604: 18/8 - added in with LC to reflect his ppt slide
- 605: 18/8 - added in with LC to reflect his ppt slide
- 606: 18/8 - added in with LC to reflect his ppt slide / Guidance: 18/8 - needs to finish on 3/11 for ETWAG / Action: 18/8 - needs to finish on 29/9 for ETWAG
- 607: 18/8 - added in with LC to reflect his ppt slide
- 608: 18/8 - added in with LC to reflect his ppt slide
- 609: 18/8 - added in with LC to reflect his ppt slide
- 610: 18/8 - added in with LC to reflect his ppt slide. 28/11 - Red because TMAG date has moved from 8/12 to 20/12 due to reduction in Dec TMAGs. No impact. No action. 20/12 - Approved at TMAG on 20/12 / Guidance: 28/11 - Red because TMAG date has moved from 8/12 to 20/12 due to reduction in Dec TMAGs. No impact. No action
- 614: 16/8- new milestones added in and date change. Approved at TMAG on 16/8. 18/10 - Red because there is an issue that is preventing the issue of PKI certificates. ~Avanade are working with GlobalSign to resolve.~A fix is in the process of being tested

| ID | WBS | Task | Type | Duration | Start | Finish | Predecessors | Complete | Baseline start | Baseline finish | Baseline duration | Baseline cost | Responsible | Involved | Task Status | Update Version | MHHS Resource Name | MHHS Programme Phase | Sched Status | RAG | Action | Milestone ID | Text29 | Tier | Artefact ID |
| --- | --- | --- | --- | --- | --- | --- | --- | --- | --- | --- | --- | --- | --- | --- | --- | --- | --- | --- | --- | --- | --- | --- | --- | --- | --- |
| 626 | 1.4.1.4.1.5.2 | **Test Data - ISD Creation** |  | 9d | 2023-08-22 A | 2023-09-01 A |  | 100% | 2023-08-22 | 2023-09-01 | 9d |  | N/A | N/A | -275.67 | 5.5 | N/A | Systems Integration Testing (SIT) |  |  |  |  |  |  |  |
| 627 | 1.4.1.4.1.5.2.1 | Set-up Market Participants and DIP ID Data |  | 8d | 2023-08-22 A | 2023-08-31 A |  | 100% | 2023-08-22 | 2023-08-31 | 8d |  | SI Test Data | SI Test, DIP, Helix |  | 5.5 | Cesar Lopes | Systems Integration Testing (SIT) | Complete | COMPLETE |  |  |  |  |  |
| 628 | 1.4.1.4.1.5.2.2 | Distribute ISD Data to Participants |  | 1d | 2023-09-01 A | 2023-09-01 A | 627 | 100% | 2023-09-01 | 2023-09-01 | 1d |  | SI Test Data | SI Test, DIP, Helix |  | 5.5 | Cesar Lopes | Systems Integration Testing (SIT) | Complete | COMPLETE |  |  |  |  |  |
| 629 | 1.4.1.4.1.5.2.3 | Test Data - ISD Creation Complete | milestone | 0d | 2023-09-01 A | 2023-09-01 A | 628 | 100% | 2023-09-01 | 2023-09-01 | 0d |  | SI Test Data | SI Test, DIP, Helix |  | 5.5 | Cesar Lopes | Systems Integration Testing (SIT) | Complete | COMPLETE | 3/8 - add as t3 milestones. Awaiting approval at TMAG | T3-TE-0083 | SITAG | T3 |  |
| 630 | 1.4.1.4.1.5.3 | **Test Data - SFTP Onboarding** |  | 70d | 2023-08-21 A | 2023-11-24 A |  | 100% | 2023-08-21 | 2023-11-24 | 70d | -0 | N/A | N/A | -275.67 | 5.5 | N/A | Systems Integration Testing (SIT) |  |  |  |  |  |  |  |
| 631 | 1.4.1.4.1.5.3.1 | Create Containers and Keys for Participants |  | 3d | 2023-08-21 A | 2023-08-23 A |  | 100% | 2023-08-21 | 2023-08-23 | 3d |  | SI Test Data | SI Test |  | 5.5 | Cesar Lopes | Systems Integration Testing (SIT) | Complete | COMPLETE |  |  |  |  |  |
| 632 | 1.4.1.4.1.5.3.2 | Share SFTP Access with Participants |  | 5d | 2023-08-24 A | 2023-08-30 A | 631 | 100% | 2023-08-24 | 2023-08-30 | 5d |  | SI Test Data | SI Test, PP |  | 5.5 | Cesar Lopes | Systems Integration Testing (SIT) | Complete | COMPLETE |  |  |  |  |  |
| 633 | 1.4.1.4.1.5.3.3 | Test SFTP Connectivity |  | 5d | 2023-08-31 A | 2023-09-06 A | 632 | 100% | 2023-08-31 | 2023-09-06 | 5d |  | SI Test Data | SI Test, PP |  | 5.5 | Cesar Lopes | Systems Integration Testing (SIT) | Complete | COMPLETE |  |  |  |  |  |
| 634 | 1.4.1.4.1.5.3.4 | Test Data - SFTP Onboarding Complete | milestone | 0d | 2023-11-24 A | 2023-11-24 A | 633FS+57d | 100% | 2023-11-24 | 2023-11-24 | 0d |  | SI Test Data | SI Test, PP |  | 5.13 | Cesar Lopes | Systems Integration Testing (SIT) | Complete | COMPLETE |  | T3-TE-0084 | SITAG | T3 |  |
| 635 | 1.4.1.4.1.5.4 | **Test Data - Provide Sample Files** |  | 10d | 2023-08-21 A | 2023-09-01 A |  | 100% | 2023-08-21 | 2023-09-01 | 10d |  | N/A | N/A | -275.67 | 5.5 | N/A | Systems Integration Testing (SIT) |  |  |  |  |  |  |  |
| 636 | 1.4.1.4.1.5.4.1 | Generate Sample Files off IF Messages |  | 8d | 2023-08-21 A | 2023-08-30 A |  | 100% | 2023-08-21 | 2023-08-30 | 8d |  | SI Test Data | SI Test |  | 5.5 | Cesar Lopes | Systems Integration Testing (SIT) | Complete | COMPLETE |  |  |  |  |  |
| 637 | 1.4.1.4.1.5.4.2 | Transmit Sample Files off IF Messages to Participants (More detail needs to be planned for a POC) |  | 2d | 2023-08-31 A | 2023-09-01 A | 636 | 100% | 2023-08-31 | 2023-09-01 | 2d |  | SI Test Data | SI Test |  | 5.5 | Cesar Lopes | Systems Integration Testing (SIT) | Complete | COMPLETE |  |  |  |  |  |
| 638 | 1.4.1.4.1.5.4.3 | Test Data - Provide Sample Files Complete | milestone | 0d | 2023-09-01 A | 2023-09-01 A | 637 | 100% | 2023-09-01 | 2023-09-01 | 0d |  | SI Test Data | SI Test |  | 5.5 | Cesar Lopes | Systems Integration Testing (SIT) | Complete | COMPLETE | 3/8 - add as t3 milestones. Awaiting approval at TMAG | T3-TE-0085 | SITAG | T3 |  |
| 639 | 1.4.1.4.1.5.5 | **Test Data - Detailed SIT Data Load Guidance** |  | 65d | 2023-09-07 A | 2023-12-06 A |  | 100% | 2023-09-07 | 2023-12-06 | 62d | -0 | N/A | N/A | -275.67 | 5.5 | N/A | Systems Integration Testing (SIT) |  |  |  |  |  |  |  |
| 640 | 1.4.1.4.1.5.5.1 | Document Guidance |  | 21d | 2023-09-07 A | 2023-10-05 A | 638FS+3d | 100% | 2023-09-07 | 2023-10-05 | 16d |  | SI Test Data | SI Test |  | 5.9 | Cesar Lopes | Systems Integration Testing (SIT) | Complete | COMPLETE |  |  |  |  |  |
| 641 | 1.4.1.4.1.5.5.2 | Provide Guidance to PPs |  | 1d | 2023-10-06 A | 2023-10-06 A | 640 | 100% | 2023-10-06 | 2023-10-06 | 1d |  | SI Test Data | SI Test |  | 5.9 | Cesar Lopes | Systems Integration Testing (SIT) | Complete | COMPLETE |  |  |  |  |  |
| 642 | 1.4.1.4.1.5.5.3 | Test Data - Detailed SIT Functional Data Load Guidance Complete | milestone | 0d | 2023-12-06 A | 2023-12-06 A | 641FS+43d | 100% | 2023-12-06 | 2023-12-06 | 0d |  | SI Test Data | SI Test |  | 5.13 | Richard Puddephatt | Systems Integration Testing (SIT) | Complete | COMPLETE |  | T3-TE-0095 | SITAG | T3 | MHHS-DEL 1545 |
| 643 | 1.4.1.4.1.5.6 | **Test Data - Population of Data Items for Testing Guidance - Draft** |  | 80d | 2023-08-17 A | 2023-12-06 A |  | 100% | 2023-08-17 | 2023-12-06 | 77d | -0 | N/A | N/A | -275.67 | 5.5 | N/A | Systems Integration Testing (SIT) |  |  |  |  |  |  |  |
| 644 | 1.4.1.4.1.5.6.1 | Document Guidance - Draft |  | 11d | 2023-08-17 A | 2023-08-31 A | 833 | 100% | 2023-08-17 | 2023-08-31 | 11d |  | SI Test Data | SI Test |  | 5.6 | Cesar Lopes | Systems Integration Testing (SIT) | Complete | COMPLETE |  |  |  |  |  |
| 645 | 1.4.1.4.1.5.6.2 | Provide Guidance to PPs - Draft |  | 1d | 2023-09-01 A | 2023-09-01 A | 644 | 100% | 2023-09-01 | 2023-09-01 | 1d |  | SI Test Data | SI Test |  | 5.6 | Cesar Lopes | Systems Integration Testing (SIT) | Complete | COMPLETE |  |  |  |  |  |
| 646 | 1.4.1.4.1.5.6.3 | Test Data - Population of Data Items for Testing Guidance - Draft Complete | milestone | 0d | 2023-12-06 A | 2023-12-06 A | 645FS+68d | 100% | 2023-12-06 | 2023-12-06 | 0d |  | SI Test Data | SI Test |  | 5.13 | Richard Puddephatt | Systems Integration Testing (SIT) | Complete | COMPLETE |  | T3-TE-0096 | SITAG | T3 | MHHS-DEL 816 |
| 647 | 1.4.1.4.1.5.7 | **Test Data - Population of Data Items for Testing Guidance - Final** |  | 87d | 2023-08-17 A | 2023-12-15 A |  | 100% | 2023-08-17 | 2023-12-15 | 45d |  | N/A | N/A | -275.67 | 5.5 | N/A | Systems Integration Testing (SIT) |  |  |  |  |  |  |  |
| 648 | 1.4.1.4.1.5.7.1 | Update Document Guidance With PPS Feedback |  | 81d | 2023-08-17 A | 2023-12-07 A | 644SS | 100% | 2023-08-17 | 2023-12-07 | 44d |  | SI Test Data | SI Test |  | 5.5 | Richard Puddephatt | Systems Integration Testing (SIT) | Complete | COMPLETE |  |  |  |  |  |
| 649 | 1.4.1.4.1.5.7.2 | Provide Final Guidance to PPs |  | 1d | 2023-12-08 A | 2023-12-08 A | 648 | 100% | 2023-12-08 | 2023-12-08 | 1d |  | SI Test Data | SI Test |  | 5.5 | Richard Puddephatt | Systems Integration Testing (SIT) | Complete | COMPLETE |  |  |  |  |  |
| 650 | 1.4.1.4.1.5.7.3 | Test Data - Population of Data Items for Testing Guidance - Final Complete | milestone | 0d | 2023-12-15 A | 2023-12-15 A | 649FS+5d | 100% | 2023-12-15 | 2023-12-15 | 0d |  | SI Test Data | SI Test |  | 5.14 | Richard Puddephatt | Systems Integration Testing (SIT) | Complete | COMPLETE |  | T3-TE-0097 | SITAG | T3 | MHHS-DEL 816 |

Notes:
- 626: 3/8 - JW and CL meeting - added in to give e more clarity around work being undertaken
- 627: 3/8 - JW and CL meeting - added in to give e more clarity around work being undertaken
- 628: 3/8 - JW and CL meeting - added in to give e more clarity around work being undertaken
- 629: 3/8 - JW and CL meeting - added in to give more clarity around work being undertaken
- 630: 3/8 - JW and CL meeting - added in to give more clarity around work being undertaken
- 631: 3/8 - JW and CL meeting - added in to give more clarity around work being undertaken
- 632: 3/8 - JW and CL meeting - added in to give more clarity around work being undertaken
- 633: 3/8 - JW and CL meeting - added in to give more clarity around work being undertaken
- 634: Approved at TMAG on 20/9. 26/9 - RP - Red because we have changed the approach to SFTP onboarding to be phased by interval. To go to TMAG for date change approval. Approved for date change at TMAG on 23/10/23
- 635: 3/8 - JW and CL meeting - added in to give more clarity around work being undertaken
- 636: 3/8 - JW and CL meeting - added in to give more clarity around work being undertaken
- 637: 3/8 - JW and CL meeting - added in to give more clarity around work being undertaken
- 638: 3/8 - JW and CL meeting - added in to give more clarity around work being undertaken
- 639: 3/8 - JW and CL meeting - added in to give more clarity around work being undertaken
- 640: 3/8 - JW and CL meeting - added in to give more clarity around work being undertaken
- 641: 3/8 - JW and CL meeting - added in to give more clarity around work being undertaken
- 642: 28/11- Red because of slow start to CIT Interval 3, doc timelines may need to be extended. Currently no impact on final doc. Aim to update the doc incrementally
- 643: 3/8 - JW and CL meeting - added in to give more clarity around work being undertaken
- 644: 3/8 - JW and CL meeting - added in to give more clarity around work being undertaken
- 645: 3/8 - JW and CL meeting - added in to give more clarity around work being undertaken
- 646: 28/11- Red because of slow start to CIT Interval 3, doc timelines may need to be extended. Currently no impact on final doc. Aim to update the doc incrementally
- 647: 3/8 - JW and CL meeting - added in to give more clarity around work being undertaken
- 648: 3/8 - JW and CL meeting - added in to give more clarity around work being undertaken
- 649: 3/8 - JW and CL meeting - added in to give more clarity around work being undertaken
- 650: 15/8 - JW and CL meeting - added in to give more clarity around work being undertaken. 12/12 - Red because we needed to provide the SRO 5 more working days to review. No impact. No action

| ID | WBS | Task | Type | Duration | Start | Finish | Predecessors | Complete | Baseline start | Baseline finish | Baseline duration | Baseline 1 start | Baseline 1 finish | Constraint | Baseline cost | Responsible | Involved | Update Version | MHHS Resource Name | MHHS Programme Phase | Sched Status | RAG | Artefact ID | Milestone ID | Text29 | Tier |
| --- | --- | --- | --- | --- | --- | --- | --- | --- | --- | --- | --- | --- | --- | --- | --- | --- | --- | --- | --- | --- | --- | --- | --- | --- | --- | --- |
| 651 | 1.4.1.4.1.5.8 | **Test Data (SIT A) Interval 1** |  | 40d | 2023-09-04 A | 2023-10-27 A |  | 100% | 2023-09-04 | 2023-10-27 | 20d | 2023-09-04 | 2023-09-29 |  |  | N/A | N/A | 5.0 | N/A | Systems Integration Testing (SIT) |  |  |  |  |  |  |
| 652 | 1.4.1.4.1.5.8.1 | Run data allocation |  | 4d | 2023-09-04 A | 2023-09-07 A | 592, 629 | 100% | 2023-09-04 | 2023-09-07 | 4d | 2023-09-04 | 2023-09-07 |  |  | SI Test |  | 5.0 | Cesar Lopes | Systems Integration Testing (SIT) | Complete | COMPLETE |  |  |  |  |
| 653 | 1.4.1.4.1.5.8.2 | Cleanse, anonymise and populate data post cut |  | 4d | 2023-09-08 A | 2023-09-13 A | 652 | 100% | 2023-09-08 | 2023-09-13 | 4d | 2023-09-08 | 2023-09-13 |  |  | SI Test |  | 5.0 | Cesar Lopes | Systems Integration Testing (SIT) | Complete | COMPLETE |  |  |  |  |
| 654 | 1.4.1.4.1.5.8.3 | Transmit data sets to PPs |  | 3d | 2023-09-15 A | 2023-09-19 A | 653 | 100% | 2023-09-15 | 2023-09-19 | 1d | 2023-09-14 | 2023-09-15 |  |  | SI Test |  | 5.0 | Cesar Lopes | Systems Integration Testing (SIT) | Complete | COMPLETE |  |  |  |  |
| 655 | 1.4.1.4.1.5.8.4 | PP - Load test data to test environments |  | 7d | 2023-09-20 A | 2023-09-28 A | 654, 638 | 100% | 2023-09-20 | 2023-09-28 | 5d | 2023-09-18 | 2023-09-22 |  |  | PP |  | 5.0 | Cesar Lopes | Systems Integration Testing (SIT) | Complete | COMPLETE |  |  |  |  |
| 656 | 1.4.1.4.1.5.8.5 | PP Check data integrity on test environment |  | 1d | 2023-09-29 A | 2023-09-29 A | 655 | 100% | 2023-09-29 | 2023-09-29 | 5d | 2023-09-25 | 2023-09-29 |  |  | PP |  | 5.0 | Cesar Lopes | Systems Integration Testing (SIT) | Complete | COMPLETE |  |  |  |  |
| 657 | 1.4.1.4.1.5.8.6 | PP submit self-declaration to Programme to confirm loading & verification of test data | milestone | 0d | 2023-09-29 A | 2023-09-29 A | 656FF | 100% | 2023-09-29 | 2023-09-29 | 0d | 2023-09-29 | 2023-09-29 |  |  | PP | SI Test | 5.0 | Cesar Lopes | Systems Integration Testing (SIT) | Complete | COMPLETE |  |  |  |  |
| 658 | 1.4.1.4.1.5.8.7 | Test Data (SIT A) Interval 1 Complete | milestone | 0d | 2023-10-27 A | 2023-10-27 A | 657FS+20d | 100% | 2023-10-27 | 2023-10-27 | 0d |  |  |  |  | SI Test | PP | 5.10 | Cesar Lopes | Systems Integration Testing (SIT) | Complete | COMPLETE | MHHS-ART148/169 | T3-TE-0073 | SITAG | T3 |
| 659 | 1.4.1.4.1.5.9 | **Other Preparation** |  | 45d | 2023-07-03 A | 2023-09-01 A |  | 100% | 2023-07-03 | 2023-09-01 | 45d | 2023-07-03 | 2023-09-01 |  |  | N/A | N/A | 5.0 | N/A | Systems Integration Testing (SIT) |  |  |  |  |  |  |
| 660 | 1.4.1.4.1.5.9.1 | Onboarding of Test Participants to Test Management Tool (Azure DevOps) |  | 45d | 2023-07-03 A | 2023-09-01 A | 619SF | 100% | 2023-07-03 | 2023-09-01 | 45d | 2023-07-03 | 2023-09-01 |  |  | SI Test | PP | 5.0 |  | Systems Integration Testing (SIT) | Complete | COMPLETE |  |  |  |  |
| 661 | 1.4.1.4.1.5.9.2 | Test Management Tool onboarding |  | 45d | 2023-07-03 A | 2023-09-01 A | 619SF | 100% | 2023-07-03 | 2023-09-01 | 45d | 2023-07-03 | 2023-09-01 |  |  | PP | SI Test | 5.0 |  | Systems Integration Testing (SIT) | Complete | COMPLETE |  |  |  |  |
| 662 | 1.4.1.4.1.5.10 | **SIT Component Integration Test Readiness Report** |  | 28d | 2023-09-14 A | 2023-10-23 A |  | 100% | 2023-09-14 | 2023-10-23 | 9d | 2023-09-11 | 2023-10-20 |  |  | N/A | N/A | 5.6 | N/A | Systems Integration Testing (SIT) |  |  |  |  |  |  |
| 663 | 1.4.1.4.1.5.10.1 | PP submit Test Readiness Report to Programme for assurance | milestone | 0d | 2023-10-20 A | 2023-10-20 A | 661, 602, 658 | 100% | 2023-10-20 | 2023-10-20 | 0d | 2023-09-29 | 2023-09-29 | start no earlier than 2023-10-09 |  | PP | SI Test | 5.6 |  | Systems Integration Testing (SIT) | Complete | COMPLETE |  |  |  |  |
| 664 | 1.4.1.4.1.5.10.2 | SI assure Test Participants' Test Readiness Reports |  | 1d | 2023-10-23 A | 2023-10-23 A | 663SS | 100% | 2023-10-23 | 2023-10-23 | 5d | 2023-10-02 | 2023-10-06 |  |  | SI Test | PP,IPA | 5.6 |  | Systems Integration Testing (SIT) | Complete | COMPLETE |  |  |  |  |
| 665 | 1.4.1.4.1.5.10.3 | SI develop Overarching SIT Component Integration Test Readiness Report |  | 23d | 2023-09-14 A | 2023-10-16 A | 588FS+40d | 100% | 2023-09-14 | 2023-10-16 | 4d | 2023-09-11 | 2023-10-06 |  |  | SI Test |  | 5.6 |  | Systems Integration Testing (SIT) | Complete | COMPLETE |  |  |  |  |
| 666 | 1.4.1.4.1.5.10.4 | Artefact review (via TMAG) and updates |  | 4d | 2023-10-17 A | 2023-10-20 A | 665 | 100% | 2023-10-17 | 2023-10-20 | 5d | 2023-10-09 | 2023-10-20 |  |  | SI Test | PP,IPA | 5.6 |  | Systems Integration Testing (SIT) | Complete | COMPLETE |  |  |  |  |
| 667 | 1.4.1.4.1.5.11 | SIT Component Integration Testing 1 Preparation Complete (incl. approval of SI SIT Component Integration Test Readiness Report) | milestone | 0d | 2023-10-27 A | 2023-10-27 A | 666FS+1d, 663, 619, 661, 658, 236, 241, 230, 250, 251, 664 | 100% | 2023-10-27 | 2023-10-27 | 0d | 2023-10-23 | 2023-10-23 |  |  | SI Test | PP,IPA | 5.11 |  | Systems Integration Testing (SIT) | Complete | COMPLETE | MHHS-ART071 | T2-TE-0250 | SITAG | T2 |
| 668 | 1.4.1.4.1.6 | **CIT Interval 2 Preparation** |  | 103d | 2023-07-03 A | 2023-11-22 A |  | 100% | 2023-07-03 | 2023-11-22 | 95d | 2022-11-16 | 2023-11-06 |  | -0 | N/A | N/A | 5.0 | N/A | Systems Integration Testing (SIT) |  |  |  |  |  |  |
| 669 | 1.4.1.4.1.6.1 | **Environments (SIT A)** |  | 43d | 2023-09-22 A | 2023-11-22 A |  | 100% | 2023-09-22 | 2023-11-22 | 35d | 2022-11-16 | 2023-10-27 |  | -0 | N/A | N/A | 5.0 | N/A | Systems Integration Testing (SIT) |  |  |  |  |  |  |
| 670 | 1.4.1.4.1.6.1.1 | SIT Participants' SIT A environments ready to start connectivity proving CIT Interval 2 | milestone | 0d | 2023-09-22 A | 2023-09-22 A |  | 100% | 2023-09-22 | 2023-09-22 | 0d | 2023-09-22 | 2023-09-22 |  |  | PP | PP,IPA | 5.6 | Simon Berry | Systems Integration Testing (SIT) | Complete | COMPLETE | MHHS-ART139 | T3-TE-0020 | SITAG | T3 |
| 671 | 1.4.1.4.1.6.1.2 | Programme Participants Ready to Start Connectivity Proving | milestone | 0d | 2023-09-22 A | 2023-09-22 A |  | 100% | 2023-09-22 | 2023-09-22 | 0d |  |  | finish no earlier than 2023-09-22 |  | PP |  | 5.10 | Simon Berry | Systems Integration Testing (SIT) | Complete | COMPLETE |  |  |  |  |
| 672 | 1.4.1.4.1.6.1.3 | Internal Connectivity Proving Phase |  | 10d | 2023-09-25 A | 2023-10-06 A | 671 | 100% | 2023-09-25 | 2023-10-06 | 10d |  |  |  |  | PP |  | 5.10 | Simon Berry | Systems Integration Testing (SIT) | Complete | COMPLETE |  |  |  |  |
| 673 | 1.4.1.4.1.6.1.4 | Internal Connectivity Proving Phase Complete | milestone | 0d | 2023-10-06 A | 2023-10-06 A | 672 | 100% | 2023-10-06 | 2023-10-06 | 0d |  |  | start no earlier than 2023-10-06 |  | PP |  | 5.10 | Simon Berry | Systems Integration Testing (SIT) | Complete | COMPLETE |  |  |  |  |
| 674 | 1.4.1.4.1.6.1.5 | DIP Onboarding Activity (1. PKI Officers and Certificates, 2. Set-up Validation, 3. End Point Creation, 4. Controlled Smoke Test ) |  | 28d | 2023-10-16 A | 2023-11-22 A | 673FS+5d | 100% | 2023-10-16 | 2023-11-22 | 20d |  |  |  |  | PP |  | 5.10 | Simon Berry | Systems Integration Testing (SIT) | Complete | COMPLETE |  |  |  |  |
| 675 | 1.4.1.4.1.6.1.6 | DIP Onboarding Complete | milestone | 0d | 2023-11-22 A | 2023-11-22 A | 674 | 100% | 2023-11-22 | 2023-11-22 | 0d |  |  |  |  | PP |  | 5.10 | Simon Berry | Systems Integration Testing (SIT) | Complete | COMPLETE |  |  |  |  |
| 676 | 1.4.1.4.1.6.1.7 | PPs Register PKI Officers and request PKI certificates Complete - Interval 2 | milestone | 0d | 2023-11-22 A | 2023-11-22 A | 675 | 100% | 2023-11-22 | 2023-11-22 | 0d |  |  |  |  | PP | DIP Provider | 5.15 | Simon Berry | Systems Integration Testing (SIT) | Complete | COMPLETE |  | T3-TE-0098 | SITAG | T3 |
| 677 | 1.4.1.4.1.6.1.8 | PP Code Deployment | milestone | 0d | 2023-10-20 A | 2023-10-20 A |  | 100% | 2023-10-20 | 2023-10-20 | 0d |  |  | start no earlier than 2023-10-20 |  | PP |  | 5.10 | Simon Berry | Systems Integration Testing (SIT) | Complete | COMPLETE |  |  |  |  |

Notes:
- 658: 28/7: CH: added in to be aT3 milestone. 10/10 - RP - Red because Avanade plan to load Test Data on week commencing 23/10, this is the earliest it can be planned due to latest code being required (M9 dependant) / Action: 28/7: CH: Needs to be set-up as a reporting milestone. 31/7: Check with Cesar if has been approved so can be baselined
- 662: Action: 21/8 - Rework with Lee
- 663: 18/8 - dates changed to reflect PIT Execution date changes advised by RG
- 664: 18/8 - dates changed to reflect PIT Execution date changes advised by RG / Action: 21/8 - Rework with Lee
- 665: 18/8 - dates changed to reflect PIT Execution date changes advised by RG / Action: 21/8 - Rework with Lee
- 666: 18/8 - dates changed to reflect PIT Execution date changes advised by RG / Action: 21/8 - Rework with Lee
- 667: Red because prep now dependant on an agreed work-off plan.
- 676: 5/12- Red because only 1 PP has successfully registered their PKI Officers; received their PKI certificates; set-up validation compete; end point creation complete; and completed controlled smoke test. The other PP is currently in Step 4 of E2E onboarding

| ID | WBS | Task | Type | Duration | Start | Finish | Predecessors | Complete | Baseline start | Baseline finish | Baseline duration | Baseline 1 start | Baseline 1 finish | Constraint | Baseline cost | Responsible | Involved | Update Version | MHHS Resource Name | MHHS Programme Phase | Sched Status | RAG | Artefact ID | Milestone ID | Text29 | Tier |
| --- | --- | --- | --- | --- | --- | --- | --- | --- | --- | --- | --- | --- | --- | --- | --- | --- | --- | --- | --- | --- | --- | --- | --- | --- | --- | --- |
| 678 | 1.4.1.4.1.6.2 | **Test Data (SIT A) Interval 2** |  | 43d | 2023-09-20 A | 2023-11-17 A |  | 100% | 2023-09-20 | 2023-11-17 | 25d | 2023-09-18 | 2023-10-20 |  |  | N/A | N/A | 5.0 | N/A | Systems Integration Testing (SIT) |  |  |  |  |  |  |
| 679 | 1.4.1.4.1.6.2.1 | Run data allocation |  | 7d | 2023-09-20 A | 2023-09-28 A | 655SS | 100% | 2023-09-20 | 2023-09-28 | 5d | 2023-09-18 | 2023-09-22 |  |  | SI Test |  | 5.0 | Cesar Lopes | Systems Integration Testing (SIT) | Complete | COMPLETE |  |  |  |  |
| 680 | 1.4.1.4.1.6.2.2 | Cleanse and populate data post cut |  | 2d | 2023-09-29 A | 2023-10-02 A | 679 | 100% | 2023-09-29 | 2023-10-02 | 5d | 2023-09-25 | 2023-09-29 |  |  | SI Test |  | 5.0 | Cesar Lopes | Systems Integration Testing (SIT) | Complete | COMPLETE |  |  |  |  |
| 681 | 1.4.1.4.1.6.2.3 | Transmit data sets to PPs |  | 1d | 2023-10-03 A | 2023-10-03 A | 680 | 100% | 2023-10-03 | 2023-10-03 | 2d | 2023-10-02 | 2023-10-03 |  |  | SI Test |  | 5.0 | Cesar Lopes | Systems Integration Testing (SIT) | Complete | COMPLETE |  |  |  |  |
| 682 | 1.4.1.4.1.6.2.4 | PP - Load test data to test environments |  | 33d | 2023-10-04 A | 2023-11-17 A | 681 | 100% | 2023-10-04 | 2023-11-17 | 8d | 2023-10-04 | 2023-10-13 |  |  | PP |  | 5.0 | Cesar Lopes | Systems Integration Testing (SIT) | Complete | COMPLETE |  |  |  |  |
| 683 | 1.4.1.4.1.6.2.5 | PP Check data integrity on test environment |  | 15d | 2023-10-23 A | 2023-11-17 A | 682FF | 100% | 2023-10-23 | 2023-11-17 | 5d | 2023-10-16 | 2023-10-20 |  |  | PP |  | 5.0 | Cesar Lopes | Systems Integration Testing (SIT) | Complete | COMPLETE |  |  |  |  |
| 684 | 1.4.1.4.1.6.2.6 | PP submit self-declaration to Programme to confirm loading & verification of test data | milestone | 0d | 2023-11-17 A | 2023-11-17 A | 683FF | 100% | 2023-11-17 | 2023-11-17 | 0d | 2023-10-20 | 2023-10-20 |  |  | PP | SI Test | 5.0 | Cesar Lopes | Systems Integration Testing (SIT) | Complete | COMPLETE |  |  |  |  |
| 685 | 1.4.1.4.1.6.2.7 | Test Data (SIT A) Interval 2 Complete | milestone | 0d | 2023-11-17 A | 2023-11-17 A | 684 | 100% | 2023-11-17 | 2023-11-17 | 0d |  |  |  |  | SI Test | PP | 5.12 | Cesar Lopes | Systems Integration Testing (SIT) | Complete | COMPLETE | MHHS-ART148/169 | T3-TE-0074 | SITAG | T3 |
| 686 | 1.4.1.4.1.6.3 | **Other Preparation** |  | 87d | 2023-07-03 A | 2023-10-31 A |  | 100% | 2023-07-03 | 2023-10-31 | 87d | 2023-07-03 | 2023-09-22 |  | -0 | N/A | N/A | 5.0 | N/A | Systems Integration Testing (SIT) |  |  |  |  |  |  |
| 687 | 1.4.1.4.1.6.3.1 | Onboarding of Test Participants to Test Management Tool (Azure DevOps) |  | 60d | 2023-07-03 A | 2023-09-22 A | 670SF | 100% | 2023-07-03 | 2023-09-22 | 60d | 2023-07-03 | 2023-09-22 |  |  | SI Test | PP | 5.0 |  | Systems Integration Testing (SIT) | Complete | COMPLETE |  |  |  |  |
| 688 | 1.4.1.4.1.6.3.2 | Test Management Tool onboarding |  | 27d | 2023-09-25 A | 2023-10-31 A | 687 | 100% | 2023-09-25 | 2023-10-31 | 27d | 2023-07-03 | 2023-09-22 |  |  | PP | SI Test | 5.0 | Simon Berry | Systems Integration Testing (SIT) | Complete | COMPLETE |  |  |  |  |
| 689 | 1.4.1.4.1.6.4 | **SIT Component Integration Test Readiness Report** |  | 25d | 2023-10-02 A | 2023-11-03 A |  | 100% | 2023-10-02 | 2023-11-03 | 25d | 2023-10-02 | 2023-11-03 |  |  | N/A | N/A | 5.0 | N/A | Systems Integration Testing (SIT) |  |  |  |  |  |  |
| 690 | 1.4.1.4.1.6.4.1 | PP submit Test Readiness Report to Programme for assurance | milestone | 0d | 2023-10-25 A | 2023-10-25 A | 602FS+18d | 100% | 2023-10-25 | 2023-10-25 | 0d | 2023-10-20 | 2023-10-20 |  |  | PP | SI Test | 5.0 |  | Systems Integration Testing (SIT) | Complete | COMPLETE |  |  |  |  |
| 691 | 1.4.1.4.1.6.4.2 | SI assure Test Participants' Test Readiness Reports |  | 2d | 2023-10-26 A | 2023-10-27 A | 690 | 100% | 2023-10-26 | 2023-10-27 | 5d | 2023-10-23 | 2023-10-27 |  |  | SI Test | PP,IPA | 5.0 |  | Systems Integration Testing (SIT) | Complete | COMPLETE |  |  |  |  |
| 692 | 1.4.1.4.1.6.4.3 | SI develop Overarching SIT Component Integration Test Readiness Report |  | 20d | 2023-10-02 A | 2023-10-27 A | 691FF | 100% | 2023-10-02 | 2023-10-27 | 20d | 2023-10-02 | 2023-10-27 |  |  | SI Test |  | 5.0 |  | Systems Integration Testing (SIT) | Complete | COMPLETE |  |  |  |  |
| 693 | 1.4.1.4.1.6.4.4 | Artefact review (via TMAG) and updates |  | 5d | 2023-10-30 A | 2023-11-03 A | 692 | 100% | 2023-10-30 | 2023-11-03 | 5d | 2023-10-30 | 2023-11-03 |  |  | SI Test | PP,IPA | 5.0 |  | Systems Integration Testing (SIT) | Complete | COMPLETE |  |  |  |  |
| 694 | 1.4.1.4.1.6.5 | SIT Component Integration Testing 2 Preparation Complete (incl. approval of SI SIT Component Integration Test Readiness Report) | milestone | 0d | 2023-11-06 A | 2023-11-06 A | 688, 693FS+1d, 670, 299 | 100% | 2023-11-06 | 2023-11-06 | 0d | 2023-11-06 | 2023-11-06 |  |  | SI Test | PP,IPA | 5.11 |  | Systems Integration Testing (SIT) | Complete | COMPLETE | MHHS-ART071 | T2-TE-0300 | SITAG | T2 |
| 695 | 1.4.1.4.1.7 | **CIT Interval 3 Preparation** |  | 54d | 2023-10-03 A | 2023-12-15 A |  | 100% | 2023-10-03 | 2023-12-15 | 91d | 2022-11-16 | 2023-11-20 |  | -0 | N/A | N/A | 5.0 | N/A | Systems Integration Testing (SIT) |  |  |  |  |  |  |
| 696 | 1.4.1.4.1.7.1 | **PIT Test Completion Report (incl. evidence)** |  | 26d | 2023-10-13 A | 2023-11-17 A |  | 100% | 2023-10-13 | 2023-11-17 | 21d | 2023-10-13 | 2023-11-10 |  |  | N/A | N/A | 5.0 | N/A | Systems Integration Testing (SIT) |  |  |  |  |  |  |
| 697 | 1.4.1.4.1.7.1.1 | Submit draft PIT Test Completion Report (incl. evidence) and submit to Programme for assurance |  | 11d | 2023-10-13 A | 2023-10-27 A |  | 100% | 2023-10-13 | 2023-10-27 | 1d | 2023-10-13 | 2023-10-13 | must start on 2023-10-13 |  | PP | SI Test | 5.0 |  | Systems Integration Testing (SIT) | Complete | COMPLETE |  |  |  |  |
| 698 | 1.4.1.4.1.7.1.2 | Finalise PIT Test Completion Report (incl. evidence) |  | 5d | 2023-10-30 A | 2023-11-03 A | 697 | 100% | 2023-10-30 | 2023-11-03 | 15d | 2023-10-16 | 2023-11-03 |  |  | PP | SI Test | 5.0 |  | Systems Integration Testing (SIT) | Complete | COMPLETE |  |  |  |  |
| 699 | 1.4.1.4.1.7.1.3 | PP PIT Completion Report (excl. Migration/Reverse Migration) submitted to Programme for assurance CIT Interval 3 | milestone | 0d | 2023-11-03 A | 2023-11-03 A | 698, 79, 95 | 100% | 2023-11-03 | 2023-11-03 | 0d | 2023-11-03 | 2023-11-03 |  |  | PP | SI Test | 5.11 |  | Systems Integration Testing (SIT) | Complete | COMPLETE |  | T3-DB-0017 | SITAG | T3 |
| 700 | 1.4.1.4.1.7.1.4 | PP Final PIT Completion Reports assured by SI |  | 10d | 2023-11-06 A | 2023-11-17 A | 699 | 100% | 2023-11-06 | 2023-11-17 | 5d | 2023-11-06 | 2023-11-10 |  |  | SI Test | PP | 5.0 |  | Systems Integration Testing (SIT) | Complete | COMPLETE |  |  |  |  |
| 701 | 1.4.1.4.1.7.2 | **Environments (SIT A)** |  | 51d | 2023-10-06 A | 2023-12-15 A |  | 100% | 2023-10-06 | 2023-12-15 | 26d | 2022-11-16 | 2023-11-10 |  | -0 | N/A | N/A | 5.0 | N/A | Systems Integration Testing (SIT) |  |  |  |  |  |  |
| 702 | 1.4.1.4.1.7.2.1 | Programme Participants Ready to Start Connectivity Proving | milestone | 0d | 2023-10-06 A | 2023-10-06 A |  | 100% | 2023-10-06 | 2023-10-06 | 0d |  |  | start no earlier than 2023-10-06 |  | PP | PP.SI Test | 5.10 | Simon Berry | Systems Integration Testing (SIT) | Complete | COMPLETE |  |  |  |  |
| 703 | 1.4.1.4.1.7.2.2 | SIT Participants' SIT A environments ready to start connectivity proving CIT Interval 3 | milestone | 0d | 2023-10-06 A | 2023-10-06 A | 702 | 100% | 2023-10-06 | 2023-10-06 | 0d | 2023-10-06 | 2023-10-06 |  |  | PP | PP,SI Test | 5.10 | Simon Berry | Systems Integration Testing (SIT) | Complete | COMPLETE | MHHS-ART139 | T3-TE-0021 | SITAG | T3 |
| 704 | 1.4.1.4.1.7.2.3 | Internal Connectivity Proving Phase |  | 10d | 2023-10-09 A | 2023-10-20 A | 702FS+1d | 100% | 2023-10-09 | 2023-10-20 | 10d |  |  |  |  | PP | PP,SI Test | 5.10 | Simon Berry | Systems Integration Testing (SIT) | Complete | COMPLETE |  |  |  |  |
| 705 | 1.4.1.4.1.7.2.4 | Internal Connectivity Proving Phase Complete | milestone | 0d | 2023-10-20 A | 2023-10-20 A | 704 | 100% | 2023-10-20 | 2023-10-20 | 0d |  |  |  |  | PP | PP,SI Test | 5.10 | Simon Berry | Systems Integration Testing (SIT) | Complete | COMPLETE |  |  |  |  |
| 706 | 1.4.1.4.1.7.2.5 | DIP Onboarding Activity (1. PKI Officers and Certificates, 2. Set-up Validation, 3. End Point Creation, 4. Controlled Smoke Test ) |  | 35d | 2023-10-30 A | 2023-12-15 A | 705FS+5d | 100% | 2023-10-30 | 2023-12-15 | 10d |  |  |  |  | PP | PP,DIP Provider | 5.10 | Simon Berry | Systems Integration Testing (SIT) | Complete | COMPLETE |  |  |  |  |
| 707 | 1.4.1.4.1.7.2.6 | DIP Onboarding Complete | milestone | 0d | 2023-12-15 A | 2023-12-15 A | 706 | 100% | 2023-12-15 | 2023-12-15 | 0d |  |  |  |  | PP | PP,DIP Provider | 5.10 | Simon Berry | Systems Integration Testing (SIT) | Complete | COMPLETE |  |  |  |  |
| 708 | 1.4.1.4.1.7.2.7 | PPs Register PKI Officers and Request PKI certificates Complete - Interval 3 | milestone | 0d | 2023-12-15 A | 2023-12-15 A | 707FF | 100% | 2023-12-15 | 2023-12-15 | 0d | 2023-10-02 | 2023-10-06 |  |  | PP | PP,DIP Provider | 5.13 | Simon Berry | Systems Integration Testing (SIT) | Complete | COMPLETE |  | T3-TE-0099 | SITAG | T3 |
| 709 | 1.4.1.4.1.7.2.8 | PP Code Deployment | milestone | 0d | 2023-11-10 A | 2023-11-10 A | 705FS+15d | 100% | 2023-11-10 | 2023-11-10 | 0d |  |  | start no earlier than 2023-10-20 |  | PP | PP | 5.10 | Simon Berry | Systems Integration Testing (SIT) | Complete | COMPLETE |  |  |  |  |

Notes:
- 685: 28/7: CH: added in to be aT3 milestone. 15/11 - Red because of Data Customisation requirement for St. Clements and additional DIP message requirement. Impact is CIT able to start on selected MPANS remaining MPANS to be fixed by 16/11 / Action: 28/7: CH: Needs to be set-up as a reporting milestone. 31/7: Check with Cesar if has been approved so can be baselined
- 694: Amber because of dependency on PPs PIT and known reduced window to review and prepare documentation. No impact currently known. No action. 7/11 - Approved at TMAG on 6/11 with work-off
- 703: Action: 30/8 - lee said date is 30/10
- 708: 09/01 - 1 participant yet to complete onboarding. Anticipated resolution unknown

| ID | WBS | Task | Type | Duration | Start | Finish | Predecessors | Complete | Baseline start | Baseline finish | Baseline duration | Baseline 1 start | Baseline 1 finish | Constraint | Baseline cost | Responsible | Involved | Update Version | MHHS Resource Name | MHHS Programme Phase | Sched Status | RAG | Artefact ID | Milestone ID | Text29 | Tier |
| --- | --- | --- | --- | --- | --- | --- | --- | --- | --- | --- | --- | --- | --- | --- | --- | --- | --- | --- | --- | --- | --- | --- | --- | --- | --- | --- |
| 710 | 1.4.1.4.1.7.3 | **Test Data (SIT A) Interval 3** |  | 34d | 2023-10-03 A | 2023-11-17 A |  | 100% | 2023-10-03 | 2023-11-17 | 25d | 2023-10-02 | 2023-11-03 |  |  | N/A | N/A | 5.0 | N/A | Systems Integration Testing (SIT) |  |  |  |  |  |  |
| 711 | 1.4.1.4.1.7.3.1 | Run data allocation |  | 4d | 2023-10-03 A | 2023-10-06 A | 681SS | 100% | 2023-10-03 | 2023-10-06 | 5d | 2023-10-02 | 2023-10-06 |  |  | SI Test |  | 5.0 | Cesar Lopes | Systems Integration Testing (SIT) | Complete | COMPLETE |  |  |  |  |
| 712 | 1.4.1.4.1.7.3.2 | Cleanse and populate data post cut |  | 5d | 2023-10-09 A | 2023-10-13 A | 711 | 100% | 2023-10-09 | 2023-10-13 | 5d | 2023-10-09 | 2023-10-13 |  |  | SI Test |  | 5.0 | Cesar Lopes | Systems Integration Testing (SIT) | Complete | COMPLETE |  |  |  |  |
| 713 | 1.4.1.4.1.7.3.3 | Transmit data sets to PPs |  | 2d | 2023-10-16 A | 2023-10-17 A | 712 | 100% | 2023-10-16 | 2023-10-17 | 2d | 2023-10-16 | 2023-10-17 |  |  | SI Test |  | 5.0 | Cesar Lopes | Systems Integration Testing (SIT) | Complete | COMPLETE |  |  |  |  |
| 714 | 1.4.1.4.1.7.3.4 | PP - Load test data to test environments |  | 8d | 2023-10-18 A | 2023-10-27 A | 713 | 100% | 2023-10-18 | 2023-10-27 | 8d | 2023-10-18 | 2023-10-27 |  |  | PP |  | 5.0 | Cesar Lopes | Systems Integration Testing (SIT) | Complete | COMPLETE |  |  |  |  |
| 715 | 1.4.1.4.1.7.3.5 | PP Check data integrity on test environment |  | 15d | 2023-10-30 A | 2023-11-17 A | 714 | 100% | 2023-10-30 | 2023-11-17 | 5d | 2023-10-30 | 2023-11-03 |  |  | PP |  | 5.0 | Cesar Lopes | Systems Integration Testing (SIT) | Complete | COMPLETE |  |  |  |  |
| 716 | 1.4.1.4.1.7.3.6 | PP submit self-declaration to Programme to confirm loading & verification of test data | milestone | 0d | 2023-11-17 A | 2023-11-17 A | 715FF | 100% | 2023-11-17 | 2023-11-17 | 0d | 2023-11-03 | 2023-11-03 |  |  | PP | SI Test | 5.0 | Cesar Lopes | Systems Integration Testing (SIT) | Complete | COMPLETE |  |  |  |  |
| 717 | 1.4.1.4.1.7.3.7 | Test Data (SIT A) Interval 3 Complete | milestone | 0d | 2023-11-17 A | 2023-11-17 A | 716 | 100% | 2023-11-17 | 2023-11-17 | 0d |  |  |  |  | SI Test | PP | 5.13 | Cesar Lopes | Systems Integration Testing (SIT) | Complete | COMPLETE | MHHS-ART148/169 | T3-TE-0075 | SITAG | T3 |
| 718 | 1.4.1.4.1.7.4 | **Other Preparation** |  | 25d | 2023-10-16 A | 2023-11-17 A |  | 100% | 2023-10-16 | 2023-11-17 | 60d | 2023-07-17 | 2023-10-06 |  |  | N/A | N/A | 5.0 | N/A | Systems Integration Testing (SIT) |  |  |  |  |  |  |
| 719 | 1.4.1.4.1.7.4.1 | Onboarding of Test Participants to Test Management Tool (Azure DevOps) |  | 25d | 2023-10-16 A | 2023-11-17 A |  | 100% | 2023-10-16 | 2023-11-17 | 60d | 2023-07-17 | 2023-10-06 | start no earlier than 2023-10-16 |  | SI Test | PP | 5.0 | Simon Berry | Systems Integration Testing (SIT) | Complete | COMPLETE |  |  |  |  |
| 720 | 1.4.1.4.1.7.4.2 | Test Management Tool onboarding |  | 25d | 2023-10-16 A | 2023-11-17 A |  | 100% | 2023-10-16 | 2023-11-17 | 60d | 2023-07-17 | 2023-10-06 | start no earlier than 2023-10-16 |  | PP | SI Test | 5.0 | Simon Berry | Systems Integration Testing (SIT) | Complete | COMPLETE |  |  |  |  |
| 721 | 1.4.1.4.1.7.5 | **SIT Component Integration Test Readiness Report** |  | 25d | 2023-10-16 A | 2023-11-17 A |  | 100% | 2023-10-16 | 2023-11-17 | 25d | 2023-10-16 | 2023-11-17 |  |  | N/A | N/A | 5.0 | N/A | Systems Integration Testing (SIT) |  |  |  |  |  |  |
| 722 | 1.4.1.4.1.7.5.1 | PP submit Test Readiness Report to Programme for assurance | milestone | 0d | 2023-11-03 A | 2023-11-03 A | 606 | 100% | 2023-11-03 | 2023-11-03 | 0d | 2023-11-03 | 2023-11-03 |  |  | PP | SI Test | 5.0 |  | Systems Integration Testing (SIT) | Complete | COMPLETE |  |  |  |  |
| 723 | 1.4.1.4.1.7.5.2 | SI assure Test Participants' Test Readiness Reports |  | 5d | 2023-11-06 A | 2023-11-10 A | 722FF+5d | 100% | 2023-11-06 | 2023-11-10 | 5d | 2023-11-06 | 2023-11-10 |  |  | SI Test | PP,IPA | 5.0 |  | Systems Integration Testing (SIT) | Complete | COMPLETE |  |  |  |  |
| 724 | 1.4.1.4.1.7.5.3 | SI develop Overarching SIT Component Integration Test Readiness Report |  | 20d | 2023-10-16 A | 2023-11-10 A | 723FF | 100% | 2023-10-16 | 2023-11-10 | 20d | 2023-10-16 | 2023-11-10 |  |  | SI Test |  | 5.0 |  | Systems Integration Testing (SIT) | Complete | COMPLETE |  |  |  |  |
| 725 | 1.4.1.4.1.7.5.4 | Artefact review (via TMAG) and updates |  | 5d | 2023-11-13 A | 2023-11-17 A | 724 | 100% | 2023-11-13 | 2023-11-17 | 5d | 2023-11-13 | 2023-11-17 |  |  | SI Test | PP,IPA | 5.0 |  | Systems Integration Testing (SIT) | Complete | COMPLETE |  |  |  |  |
| 726 | 1.4.1.4.1.7.6 | SIT Component Integration Testing 3 Preparation Complete (incl. approval of SI SIT Component Integration Test Readiness Report) | milestone | 0d | 2023-11-20 A | 2023-11-20 A | 725FS+1d, 699, 703, 722, 720, 717, 317 | 100% | 2023-11-20 | 2023-11-20 | 0d | 2023-11-20 | 2023-11-20 |  |  | SI Test | PP,IPA | 5.12 |  | Systems Integration Testing (SIT) | Complete | COMPLETE | MHHS-ART071 | T2-TE-0350 | SITAG | T2 |
| 727 | 1.4.1.4.1.8 | **CIT Interval 4 Preparation** |  | 36d | 2023-10-16 A | 2023-12-04 A |  | 100% | 2023-10-16 | 2023-12-04 | 36d | 2022-11-16 | 2023-12-04 |  | -0 | N/A | N/A | 5.0 | N/A | Systems Integration Testing (SIT) |  |  |  |  |  |  |
| 728 | 1.4.1.4.1.8.1 | **PIT Test Completion Report (incl. evidence)** |  | 21d | 2023-10-27 A | 2023-11-24 A |  | 100% | 2023-10-27 | 2023-11-24 | 21d | 2023-10-27 | 2023-11-24 |  |  | N/A | N/A | 5.0 | N/A | Systems Integration Testing (SIT) |  |  |  |  |  |  |
| 729 | 1.4.1.4.1.8.1.1 | Submit draft PIT Test Completion Report (incl. evidence) and submit to Programme for assurance |  | 1d | 2023-10-27 A | 2023-10-27 A |  | 100% | 2023-10-27 | 2023-10-27 | 1d | 2023-10-27 | 2023-10-27 | must start on 2023-10-27 |  | PP | SI Test | 5.0 |  | Systems Integration Testing (SIT) | Complete | COMPLETE |  |  |  |  |
| 730 | 1.4.1.4.1.8.1.2 | Finalise PIT Test Completion Report (incl. evidence) |  | 15d | 2023-10-30 A | 2023-11-17 A | 729 | 100% | 2023-10-30 | 2023-11-17 | 15d | 2023-10-30 | 2023-11-17 |  |  | PP | SI Test | 5.0 |  | Systems Integration Testing (SIT) | Complete | COMPLETE |  |  |  |  |
| 731 | 1.4.1.4.1.8.1.3 | PP PIT Completion Report (excl. Migration/Reverse Migration) submitted to Programme for assurance CIT Interval 4 | milestone | 0d | 2023-11-17 A | 2023-11-17 A | 730, 79, 95 | 100% | 2023-11-17 | 2023-11-17 | 0d | 2023-11-17 | 2023-11-17 |  |  | PP | SI Test | 5.13 |  | Systems Integration Testing (SIT) | Complete | COMPLETE |  | T3-DB-0019 | SITAG | T3 |
| 732 | 1.4.1.4.1.8.1.4 | PP Final PIT Completion Reports assured by SI |  | 5d | 2023-11-20 A | 2023-11-24 A | 731 | 100% | 2023-11-20 | 2023-11-24 | 5d | 2023-11-20 | 2023-11-24 |  |  | SI Test | PP | 5.0 |  | Systems Integration Testing (SIT) | Complete | COMPLETE |  |  |  |  |
| 733 | 1.4.1.4.1.8.2 | **Environments (SIT A)** |  | 25d | 2023-10-23 A | 2023-11-24 A |  | 100% | 2023-10-23 | 2023-11-24 | 25d | 2022-11-16 | 2023-11-24 |  | -0 | N/A | N/A | 5.0 | N/A | Systems Integration Testing (SIT) |  |  |  |  |  |  |
| 734 | 1.4.1.4.1.8.2.1 | Programme Participants Ready to Start Connectivity Proving | milestone | 0d | 2023-10-23 A | 2023-10-23 A |  | 100% | 2023-10-23 | 2023-10-23 | 0d |  |  | start no earlier than 2023-10-23 |  | PP |  | 5.10 | Simon Berry | Systems Integration Testing (SIT) | Complete | COMPLETE |  |  |  |  |
| 735 | 1.4.1.4.1.8.2.2 | SIT Participants' SIT A environments ready to start connectivity proving CIT Interval 4 | milestone | 0d | 2023-10-23 A | 2023-10-23 A | 734 | 100% | 2023-10-23 | 2023-10-23 | 0d | 2023-10-20 | 2023-10-20 |  |  | PP | PP,IPA | 5.10 | Simon Berry | Systems Integration Testing (SIT) | Complete | COMPLETE | MHHS-ART139 | T3-TE-0022 | SITAG | T3 |
| 736 | 1.4.1.4.1.8.2.3 | Internal Connectivity Proving Phase |  | 10d | 2023-10-23 A | 2023-11-03 A | 735 | 100% | 2023-10-23 | 2023-11-03 | 10d |  |  |  |  | PP |  | 5.10 | Simon Berry | Systems Integration Testing (SIT) | Complete | COMPLETE |  |  |  |  |
| 737 | 1.4.1.4.1.8.2.4 | Internal Connectivity Proving Phase Complete | milestone | 0d | 2023-11-03 A | 2023-11-03 A | 736 | 100% | 2023-11-03 | 2023-11-03 | 0d |  |  |  |  | PP |  | 5.10 | Simon Berry | Systems Integration Testing (SIT) | Complete | COMPLETE |  |  |  |  |
| 738 | 1.4.1.4.1.8.2.5 | DIP Onboarding Activity (1. PKI Officers and Certificates, 2. Set-up Validation, 3. End Point Creation, 4. Controlled Smoke Test ) |  | 10d | 2023-11-13 A | 2023-11-24 A | 737FS+5d | 100% | 2023-11-13 | 2023-11-24 | 10d |  |  |  |  | PP |  | 5.10 | Simon Berry | Systems Integration Testing (SIT) | Complete | COMPLETE |  |  |  |  |
| 739 | 1.4.1.4.1.8.2.6 | DIP Onboarding Complete | milestone | 0d | 2023-11-24 A | 2023-11-24 A | 738 | 100% | 2023-11-24 | 2023-11-24 | 0d |  |  |  |  | PP |  | 5.10 | Simon Berry | Systems Integration Testing (SIT) | Complete | COMPLETE |  |  |  |  |
| 740 | 1.4.1.4.1.8.2.7 | PPs register PKI Officers and Request PKI Certificates Complete - Interval 4 | milestone | 0d | 2023-11-24 A | 2023-11-24 A | 739 | 100% | 2023-11-24 | 2023-11-24 | 0d |  |  |  |  | PP | DIP Provider | 5.16 | Simon Berry | Systems Integration Testing (SIT) | Complete | COMPLETE |  | T3-TE-0100 | SITAG | T3 |
| 741 | 1.4.1.4.1.8.2.8 | PP Code Deployment | milestone | 0d | 2023-11-17 A | 2023-11-17 A |  | 100% | 2023-11-17 | 2023-11-17 | 0d |  |  | start no earlier than 2023-11-17 |  | PP |  | 5.10 | Simon Berry | Systems Integration Testing (SIT) | Complete | COMPLETE |  |  |  |  |

Notes:
- 717: 28/7: CH: added in to be aT3 milestone. 14/11-Red because 8 out of 9 participants complete. Final data checks from PP to be made this week. No impact to CIT interval 3 start. / Action: 28/7: CH: Needs to be set-up as a reporting milestone. 31/7: Check with Cesar if has been approved so can be baselined
- 731: 21/11-Red because not all received. Reminders sent. No impact. No issue
- 740: 16/02 - Red because 2 participants yet to complete onboarding. Completed 19/1/24

| ID | WBS | Task | Type | Duration | Start | Finish | Predecessors | Complete | Baseline start | Baseline finish | Baseline duration | Baseline 1 start | Baseline 1 finish | Constraint | Baseline cost | Responsible | Involved | Update Version | MHHS Resource Name | MHHS Programme Phase | Sched Status | RAG | Artefact ID | Milestone ID | Text29 | Tier |
| --- | --- | --- | --- | --- | --- | --- | --- | --- | --- | --- | --- | --- | --- | --- | --- | --- | --- | --- | --- | --- | --- | --- | --- | --- | --- | --- |
| 742 | 1.4.1.4.1.8.3 | **Test Data (SIT A) Interval 4** |  | 30d | 2023-10-23 A | 2023-12-01 A |  | 100% | 2023-10-23 | 2023-12-01 | 25d | 2023-10-16 | 2023-11-17 |  |  | N/A | N/A | 5.0 | N/A | Systems Integration Testing (SIT) |  |  |  |  |  |  |
| 743 | 1.4.1.4.1.8.3.1 | Run data allocation |  | 5d | 2023-10-23 A | 2023-10-27 A | 712FS+5d | 100% | 2023-10-23 | 2023-10-27 | 5d | 2023-10-16 | 2023-10-20 |  |  | SI Test |  | 5.0 | Cesar Lopes | Systems Integration Testing (SIT) | Complete | COMPLETE |  |  |  |  |
| 744 | 1.4.1.4.1.8.3.2 | Cleanse and populate data post cut |  | 2d | 2023-10-30 A | 2023-10-31 A | 743 | 100% | 2023-10-30 | 2023-10-31 | 5d | 2023-10-23 | 2023-10-27 |  |  | SI Test |  | 5.0 | Cesar Lopes | Systems Integration Testing (SIT) | Complete | COMPLETE |  |  |  |  |
| 745 | 1.4.1.4.1.8.3.3 | Transmit data sets to PPs |  | 5d | 2023-11-01 A | 2023-11-07 A | 744 | 100% | 2023-11-01 | 2023-11-07 | 2d | 2023-10-30 | 2023-10-31 |  |  | SI Test |  | 5.0 | Cesar Lopes | Systems Integration Testing (SIT) | Complete | COMPLETE |  |  |  |  |
| 746 | 1.4.1.4.1.8.3.4 | PP - Load test data to test environments |  | 5d | 2023-11-08 A | 2023-11-14 A | 745 | 100% | 2023-11-08 | 2023-11-14 | 8d | 2023-11-01 | 2023-11-10 |  |  | PP |  | 5.0 | Cesar Lopes | Systems Integration Testing (SIT) | Complete | COMPLETE |  |  |  |  |
| 747 | 1.4.1.4.1.8.3.5 | PP Check data integrity on test environment |  | 13d | 2023-11-15 A | 2023-12-01 A | 746 | 100% | 2023-11-15 | 2023-12-01 | 5d | 2023-11-13 | 2023-11-17 |  |  | PP |  | 5.0 | Richard Puddephatt | Systems Integration Testing (SIT) | Complete | COMPLETE |  |  |  |  |
| 748 | 1.4.1.4.1.8.3.6 | PP submit self-declaration to Programme to confirm loading & verification of test data | milestone | 0d | 2023-12-01 A | 2023-12-01 A | 747FF | 100% | 2023-12-01 | 2023-12-01 | 0d | 2023-11-17 | 2023-11-17 |  |  | PP | SI Test | 5.0 | Richard Puddephatt | Systems Integration Testing (SIT) | Complete | COMPLETE |  |  |  |  |
| 749 | 1.4.1.4.1.8.3.7 | Test Data (SIT A) Interval 4 Complete | milestone | 0d | 2023-12-01 A | 2023-12-01 A | 748 | 100% | 2023-12-01 | 2023-12-01 | 0d |  |  |  |  | SI Test | PP | 5.13 | Richard Puddephatt | Systems Integration Testing (SIT) | Complete | COMPLETE | MHHS-ART148/169 | T3-TE-0076 | SITAG | T3 |
| 750 | 1.4.1.4.1.8.4 | **Other Preparation** |  | 25d | 2023-10-30 A | 2023-12-01 A |  | 100% | 2023-10-30 | 2023-12-01 | 25d | 2023-07-31 | 2023-10-20 |  | -0 | N/A | N/A | 5.0 | N/A | Systems Integration Testing (SIT) |  |  |  |  |  |  |
| 751 | 1.4.1.4.1.8.4.1 | Onboarding of Test Participants to Test Management Tool (Azure DevOps) |  | 25d | 2023-10-30 A | 2023-12-01 A |  | 100% | 2023-10-30 | 2023-12-01 | 25d | 2023-07-31 | 2023-10-20 | start no earlier than 2023-10-30 |  | SI Test | PP | 5.0 | Simon Berry | Systems Integration Testing (SIT) | Complete | COMPLETE |  |  |  |  |
| 752 | 1.4.1.4.1.8.4.2 | Test Management Tool onboarding |  | 25d | 2023-10-30 A | 2023-12-01 A |  | 100% | 2023-10-30 | 2023-12-01 | 25d | 2023-07-31 | 2023-10-20 | start no earlier than 2023-10-30 |  | PP | SI Test | 5.0 | Simon Berry | Systems Integration Testing (SIT) | Complete | COMPLETE |  |  |  |  |
| 753 | 1.4.1.4.1.8.5 | **SIT Component Integration Test Readiness Report** |  | 27d | 2023-10-16 A | 2023-11-21 A |  | 100% | 2023-10-16 | 2023-11-21 | 25d | 2023-10-30 | 2023-12-01 |  |  | N/A | N/A | 5.0 | N/A | Systems Integration Testing (SIT) |  |  |  |  |  |  |
| 754 | 1.4.1.4.1.8.5.1 | PP submit Test Readiness Report to Programme for assurance | milestone | 0d | 2023-11-03 A | 2023-11-03 A | 606 | 100% | 2023-11-03 | 2023-11-03 | 0d | 2023-11-17 | 2023-11-17 |  |  | PP | SI Test | 5.0 |  | Systems Integration Testing (SIT) | Complete | COMPLETE |  |  |  |  |
| 755 | 1.4.1.4.1.8.5.2 | SI assure Test Participants' Test Readiness Reports |  | 5d | 2023-11-06 A | 2023-11-10 A | 754FF+5d | 100% | 2023-11-06 | 2023-11-10 | 5d | 2023-11-20 | 2023-11-24 |  |  | SI Test | PP,IPA | 5.0 |  | Systems Integration Testing (SIT) | Complete | COMPLETE |  |  |  |  |
| 756 | 1.4.1.4.1.8.5.3 | SI develop Overarching SIT Component Integration Test Readiness Report |  | 20d | 2023-10-16 A | 2023-11-10 A | 755FF | 100% | 2023-10-16 | 2023-11-10 | 20d | 2023-10-30 | 2023-11-24 |  |  | SI Test |  | 5.0 |  | Systems Integration Testing (SIT) | Complete | COMPLETE |  |  |  |  |
| 757 | 1.4.1.4.1.8.5.4 | Artefact review (via SITAG) and updates |  | 7d | 2023-11-13 A | 2023-11-21 A | 756 | 100% | 2023-11-13 | 2023-11-21 | 5d | 2023-11-27 | 2023-12-01 |  |  | SI Test | PP,IPA | 5.0 |  | Systems Integration Testing (SIT) | Complete | COMPLETE |  |  |  |  |
| 758 | 1.4.1.4.1.8.6 | SIT Component Integration Testing 4 Preparation Complete (incl. approval of SI SIT Component Integration Test Readiness Report) | milestone | 0d | 2023-12-04 A | 2023-12-04 A | 757FS+2d, 731, 735, 754, 749, 334FS+1d | 100% | 2023-12-04 | 2023-12-04 | 0d | 2023-12-04 | 2023-12-04 |  |  | SI Test | PP,IPA | 5.13 |  | Systems Integration Testing (SIT) | Complete | COMPLETE | MHHS-ART071 | T2-TE-0400 | SITAG | T2 |
| 759 | 1.4.1.4.1.9 | **CIT Interval 5 Preparation** |  | 53d | 2023-11-01 A | 2024-01-12 A |  | 100% | 2023-11-01 | 2024-01-12 | 55d | 2022-11-16 | 2024-01-08 |  | -0 | N/A | N/A | 5.0 | N/A | Systems Integration Testing (SIT) |  |  |  |  |  |  |
| 760 | 1.4.1.4.1.9.1 | **PIT Test Completion Report (incl. evidence)** |  | 21d | 2023-11-17 A | 2023-12-15 A |  | 100% | 2023-11-17 | 2023-12-15 | 21d | 2023-11-17 | 2023-12-15 |  |  | N/A | N/A | 5.0 | N/A | Systems Integration Testing (SIT) |  |  |  |  |  |  |
| 761 | 1.4.1.4.1.9.1.1 | Submit draft PIT Test Completion Report (incl. evidence) and submit to Programme for assurance |  | 1d | 2023-11-17 A | 2023-11-17 A |  | 100% | 2023-11-17 | 2023-11-17 | 1d | 2023-11-17 | 2023-11-17 | must start on 2023-11-17 |  | PP | SI Test | 5.0 | Lee Cox | Systems Integration Testing (SIT) | Complete | COMPLETE |  |  |  |  |
| 762 | 1.4.1.4.1.9.1.2 | Finalise PIT Test Completion Report (incl. evidence) |  | 15d | 2023-11-20 A | 2023-12-08 A | 761 | 100% | 2023-11-20 | 2023-12-08 | 15d | 2023-11-20 | 2023-12-08 |  |  | PP | SI Test | 5.0 | Lee Cox | Systems Integration Testing (SIT) | Complete | COMPLETE |  |  |  |  |
| 763 | 1.4.1.4.1.9.1.3 | PP PIT Completion Report (excl. Migration/Reverse Migration) submitted to Programme for assurance CIT Interval 5 | milestone | 0d | 2023-12-08 A | 2023-12-08 A | 762, 79, 95 | 100% | 2023-12-08 | 2023-12-08 | 0d | 2023-12-08 | 2023-12-08 |  |  | PP | SI Test | 5.14 | Lee Cox | Systems Integration Testing (SIT) | Complete | COMPLETE |  | T3-DB-0021 | SITAG | T3 |
| 764 | 1.4.1.4.1.9.1.4 | PP Final PIT Completion Reports assured by SI |  | 5d | 2023-12-11 A | 2023-12-15 A | 763 | 100% | 2023-12-11 | 2023-12-15 | 5d | 2023-12-11 | 2023-12-15 |  |  | SI Test | PP | 5.0 | Lee Cox | Systems Integration Testing (SIT) | Complete | COMPLETE |  |  |  |  |
| 765 | 1.4.1.4.1.9.2 | **Environments (SIT A)** |  | 21d | 2023-11-10 A | 2023-12-08 A |  | 100% | 2023-11-10 | 2023-12-08 | 21d | 2022-11-16 | 2023-12-15 |  | -0 | N/A | N/A | 5.0 | N/A | Systems Integration Testing (SIT) |  |  |  |  |  |  |
| 766 | 1.4.1.4.1.9.2.1 | Programme Participants Ready to Start Connectivity Proving | milestone | 0d | 2023-11-10 A | 2023-11-10 A |  | 100% | 2023-11-10 | 2023-11-10 | 0d |  |  | start no earlier than 2023-11-10 |  | PP |  | 5.10 | Simon Berry | Systems Integration Testing (SIT) | Complete | COMPLETE |  |  |  |  |
| 767 | 1.4.1.4.1.9.2.2 | SIT Participants' SIT A environments ready to start connectivity proving CIT Interval 5 | milestone | 0d | 2023-11-10 A | 2023-11-10 A | 766 | 100% | 2023-11-10 | 2023-11-10 | 0d | 2023-11-10 | 2023-11-10 |  |  | PP | PP,IPA | 5.6 | Simon Berry | Systems Integration Testing (SIT) | Complete | COMPLETE | MHHS-ART139 | T3-TE-0023 | SITAG | T3 |
| 768 | 1.4.1.4.1.9.2.3 | Internal Connectivity Proving Phase |  | 10d | 2023-11-13 A | 2023-11-24 A | 766FS+1d | 100% | 2023-11-13 | 2023-11-24 | 10d |  |  |  |  | PP |  | 5.10 | Simon Berry | Systems Integration Testing (SIT) | Complete | COMPLETE |  |  |  |  |
| 769 | 1.4.1.4.1.9.2.4 | Internal Connectivity Proving Phase Complete | milestone | 0d | 2023-11-24 A | 2023-11-24 A | 768 | 100% | 2023-11-24 | 2023-11-24 | 0d |  |  |  |  | PP |  | 5.10 | Simon Berry | Systems Integration Testing (SIT) | Complete | COMPLETE |  |  |  |  |
| 770 | 1.4.1.4.1.9.2.5 | DIP Onboarding Activity (1. PKI Officers and Certificates, 2. Set-up Validation, 3. End Point Creation, 4. Controlled Smoke Test ) |  | 10d | 2023-11-27 A | 2023-12-08 A | 769 | 100% | 2023-11-27 | 2023-12-08 | 10d |  |  |  |  | PP |  | 5.10 | Simon Berry | Systems Integration Testing (SIT) | Complete | COMPLETE |  |  |  |  |
| 771 | 1.4.1.4.1.9.2.6 | DIP Onboarding Complete | milestone | 0d | 2023-12-08 A | 2023-12-08 A | 770 | 100% | 2023-12-08 | 2023-12-08 | 0d |  |  |  |  | PP |  | 5.10 | Simon Berry | Systems Integration Testing (SIT) | Complete | COMPLETE |  |  |  |  |
| 772 | 1.4.1.4.1.9.2.7 | PPs register PKI Officers and Request PKI Certificates Complete - Interval 5 | milestone | 0d | 2023-12-08 A | 2023-12-08 A | 771 | 100% | 2023-12-08 | 2023-12-08 | 0d | 2023-11-06 | 2023-11-10 |  |  | PP | DIP Provider | 5.17 | Simon Berry | Systems Integration Testing (SIT) | Complete | COMPLETE |  | T3-TE-0101 | SITAG | T3 |
| 773 | 1.4.1.4.1.9.2.8 | PP Code Deployment | milestone | 0d | 2023-12-08 A | 2023-12-08 A | 772 | 100% | 2023-12-08 | 2023-12-08 | 0d |  |  | start no earlier than 2023-10-20 |  | PP |  | 5.10 | Simon Berry | Systems Integration Testing (SIT) | Complete | COMPLETE |  |  |  |  |

Notes:
- 749: 28/11 - red because data was delivered 1 week late. This led to an onward impact. We expect data to be loaded and checked by 1/12. No impact on CIT Tests Start date
- 758: 5/12 - Approved at Etmag on 4/12 with work off plan
- 763: 4/12- Amber because not all received yet. No impact. No action. 19/12 - complete on 14/12
- 772: 16/01- Red because 1 has yet to complete onboarding. 30/1 - Completed on 26/1/24

| ID | WBS | Task | Type | Duration | Start | Finish | Predecessors | Complete | Baseline start | Baseline finish | Baseline duration | Baseline 1 start | Baseline 1 finish | Constraint | Baseline cost | Responsible | Involved | Update Version | MHHS Resource Name | MHHS Programme Phase | Sched Status | RAG | Artefact ID | Milestone ID | Text29 | Tier |
| --- | --- | --- | --- | --- | --- | --- | --- | --- | --- | --- | --- | --- | --- | --- | --- | --- | --- | --- | --- | --- | --- | --- | --- | --- | --- | --- |
| 774 | 1.4.1.4.1.9.3 | **Test Data (SIT A) Interval 5** |  | 33d | 2023-11-01 A | 2023-12-15 A |  | 100% | 2023-11-01 | 2023-12-15 | 30d | 2023-10-30 | 2023-12-08 |  |  | N/A | N/A | 5.0 | N/A | Systems Integration Testing (SIT) |  |  |  |  |  |  |
| 775 | 1.4.1.4.1.9.3.1 | Run data allocation |  | 5d | 2023-11-01 A | 2023-11-07 A | 745SS | 100% | 2023-11-01 | 2023-11-07 | 10d | 2023-10-30 | 2023-11-10 |  |  | SI Test |  | 5.0 | Cesar Lopes | Systems Integration Testing (SIT) | Complete | COMPLETE |  |  |  |  |
| 776 | 1.4.1.4.1.9.3.2 | Cleanse and populate data post cut |  | 8d | 2023-11-08 A | 2023-11-17 A | 775 | 100% | 2023-11-08 | 2023-11-17 | 5d | 2023-11-13 | 2023-11-17 |  |  | SI Test |  | 5.0 | Cesar Lopes | Systems Integration Testing (SIT) | Complete | COMPLETE |  |  |  |  |
| 777 | 1.4.1.4.1.9.3.3 | Transmit data sets to PPs |  | 2d | 2023-11-20 A | 2023-11-21 A | 776 | 100% | 2023-11-20 | 2023-11-21 | 2d | 2023-11-20 | 2023-11-21 |  |  | SI Test |  | 5.0 | Cesar Lopes | Systems Integration Testing (SIT) | Complete | COMPLETE |  |  |  |  |
| 778 | 1.4.1.4.1.9.3.4 | PP - Load test data to test environments |  | 8d | 2023-11-22 A | 2023-12-01 A | 777 | 100% | 2023-11-22 | 2023-12-01 | 8d | 2023-11-22 | 2023-12-01 |  |  | PP |  | 5.0 | Richard Puddephatt | Systems Integration Testing (SIT) | Complete | COMPLETE |  |  |  |  |
| 779 | 1.4.1.4.1.9.3.5 | PP Check data integrity on test environment |  | 10d | 2023-12-04 A | 2023-12-15 A | 778 | 100% | 2023-12-04 | 2023-12-15 | 5d | 2023-12-04 | 2023-12-08 |  |  | PP |  | 5.0 | Richard Puddephatt | Systems Integration Testing (SIT) | Complete | COMPLETE |  |  |  |  |
| 780 | 1.4.1.4.1.9.3.6 | PP submit self-declaration to Programme to confirm loading & verification of test data | milestone | 0d | 2023-12-15 A | 2023-12-15 A | 779FF | 100% | 2023-12-15 | 2023-12-15 | 0d | 2023-12-08 | 2023-12-08 |  |  | PP | SI Test | 5.0 | Richard Puddephatt | Systems Integration Testing (SIT) | Complete | COMPLETE |  |  |  |  |
| 781 | 1.4.1.4.1.9.3.7 | Test Data (SIT A) Interval 5 Complete | milestone | 0d | 2023-12-15 A | 2023-12-15 A | 780 | 100% | 2023-12-15 | 2023-12-15 | 0d |  |  |  |  | SI Test | PP | 5.14 | Richard Puddephatt | Systems Integration Testing (SIT) | Complete | COMPLETE | MHHS-ART148/169 | T3-TE-0077 | SITAG | T3 |
| 782 | 1.4.1.4.1.9.4 | **Other Preparation** |  | 40d | 2023-11-20 A | 2024-01-12 A |  | 100% | 2023-11-20 | 2024-01-12 | 40d | 2023-08-21 | 2023-11-10 |  | -0 | N/A | N/A | 5.0 | N/A | Systems Integration Testing (SIT) |  |  |  |  |  |  |
| 783 | 1.4.1.4.1.9.4.1 | Onboarding of Test Participants to Test Management Tool (Azure DevOps) |  | 40d | 2023-11-20 A | 2024-01-12 A |  | 100% | 2023-11-20 | 2024-01-12 | 40d | 2023-08-21 | 2023-11-10 | start no earlier than 2023-11-20 |  | SI Test | PP | 5.0 | Simon Berry | Systems Integration Testing (SIT) | Complete | COMPLETE |  |  |  |  |
| 784 | 1.4.1.4.1.9.4.2 | Test Management Tool onboarding |  | 36d | 2023-11-20 A | 2024-01-08 A |  | 100% | 2023-11-20 | 2024-01-08 | 36d | 2023-08-21 | 2023-11-10 | start no earlier than 2023-11-20 |  | PP | SI Test | 5.0 | Simon Berry | Systems Integration Testing (SIT) | Complete | COMPLETE |  |  |  |  |
| 785 | 1.4.1.4.1.9.5 | **SIT Component Integration Test Readiness Report** |  | 35d | 2023-11-20 A | 2024-01-05 A |  | 100% | 2023-11-20 | 2024-01-05 | 35d | 2023-11-20 | 2024-01-05 |  |  | N/A | N/A | 5.0 | N/A | Systems Integration Testing (SIT) |  |  |  |  |  |  |
| 786 | 1.4.1.4.1.9.5.1 | PP submit Test Readiness Report to Programme for assurance | milestone | 0d | 2023-12-08 A | 2023-12-08 A | 610 | 100% | 2023-12-08 | 2023-12-08 | 0d | 2023-12-08 | 2023-12-08 |  |  | PP | SI Test | 5.0 | Lee Cox | Systems Integration Testing (SIT) | Complete | COMPLETE |  |  |  |  |
| 787 | 1.4.1.4.1.9.5.2 | SI assure Test Participants' Test Readiness Reports |  | 5d | 2023-12-11 A | 2023-12-15 A | 786FF+5d | 100% | 2023-12-11 | 2023-12-15 | 5d | 2023-12-11 | 2023-12-15 |  |  | SI Test | PP,IPA | 5.0 | Lee Cox | Systems Integration Testing (SIT) | Complete | COMPLETE |  |  |  |  |
| 788 | 1.4.1.4.1.9.5.3 | SI develop Overarching SIT Component Integration Test Readiness Report |  | 20d | 2023-11-20 A | 2023-12-15 A | 787FF | 100% | 2023-11-20 | 2023-12-15 | 20d | 2023-11-20 | 2023-12-15 |  |  | SI Test |  | 5.0 | Lee Cox | Systems Integration Testing (SIT) | Complete | COMPLETE |  |  |  |  |
| 789 | 1.4.1.4.1.9.5.4 | Artefact review (via SITAG) and updates |  | 15d | 2023-12-18 A | 2024-01-05 A | 788 | 100% | 2023-12-18 | 2024-01-05 | 15d | 2023-12-18 | 2024-01-05 |  |  | SI Test | PP,IPA | 5.0 | Lee Cox | Systems Integration Testing (SIT) | Complete | COMPLETE |  |  |  |  |
| 790 | 1.4.1.4.1.9.6 | SIT Component Integration Testing 5 Preparation Complete (incl. approval of SI SIT Component Integration Test Readiness Report) | milestone | 0d | 2024-01-08 A | 2024-01-08 A | 789FS+1d, 763, 767, 784, 786, 781, 436, 419 | 100% | 2024-01-08 | 2024-01-08 | 0d | 2024-01-08 | 2024-01-08 |  |  | SI Test | PP,IPA | 5.15 |  | Systems Integration Testing (SIT) | Complete | COMPLETE | MHHS-ART071 | T2-TE-0450 | SITAG | T2 |
| 791 | 1.4.1.4.1.10 | **CIT Interval 6 Preparation** |  | 45d | 2023-11-20 A | 2024-01-19 A |  | 100% | 2023-11-20 | 2024-01-19 | 46d | 2022-11-16 | 2024-01-22 |  | -0 | N/A | N/A | 5.0 | N/A | Systems Integration Testing (SIT) |  |  |  |  |  |  |
| 792 | 1.4.1.4.1.10.1 | **PIT Test Completion Report (incl. evidence)** |  | 31d | 2023-12-01 A | 2024-01-12 A |  | 100% | 2023-12-01 | 2024-01-12 | 31d | 2023-12-01 | 2024-01-12 |  |  | N/A | N/A | 5.0 | N/A | Systems Integration Testing (SIT) |  |  |  |  |  |  |
| 793 | 1.4.1.4.1.10.1.1 | Submit draft PIT Test Completion Report (incl. evidence) and submit to Programme for assurance |  | 1d | 2023-12-01 A | 2023-12-01 A |  | 100% | 2023-12-01 | 2023-12-01 | 1d | 2023-12-01 | 2023-12-01 | must start on 2023-12-01 |  | PP | SI Test | 5.0 |  | Systems Integration Testing (SIT) | Complete | COMPLETE |  |  |  |  |
| 794 | 1.4.1.4.1.10.1.2 | Finalise PIT Test Completion Report (incl. evidence) |  | 25d | 2023-12-04 A | 2024-01-05 A | 793 | 100% | 2023-12-04 | 2024-01-05 | 25d | 2023-12-04 | 2024-01-05 |  |  | PP | SI Test | 5.0 |  | Systems Integration Testing (SIT) | Complete | COMPLETE |  |  |  |  |
| 795 | 1.4.1.4.1.10.1.3 | PP PIT Completion Report (excl. Migration/Reverse Migration) submitted to Programme for assurance CIT Interval 6 | milestone | 0d | 2024-01-05 A | 2024-01-05 A | 794, 79, 95, 256, 261, 264 | 100% | 2024-01-05 | 2024-01-05 | 0d | 2024-01-05 | 2024-01-05 |  |  | PP | SI Test | 5.19 |  | Systems Integration Testing (SIT) | Complete | COMPLETE |  | T3-DB-0023 | SITAG | T3 |
| 796 | 1.4.1.4.1.10.1.4 | PP Final PIT Completion Reports assured by SI |  | 5d | 2024-01-08 A | 2024-01-12 A | 795 | 100% | 2024-01-08 | 2024-01-12 | 5d | 2024-01-08 | 2024-01-12 |  |  | SI Test | PP | 5.19 |  | Systems Integration Testing (SIT) | Complete | COMPLETE |  |  |  |  |
| 797 | 1.4.1.4.1.10.2 | **Environments (SIT A)** |  | 30d | 2023-11-24 A | 2024-01-05 A |  | 100% | 2023-11-24 | 2024-01-05 | 30d | 2022-11-16 | 2024-01-05 |  | -0 | N/A | N/A | 5.0 | N/A | Systems Integration Testing (SIT) |  |  |  |  |  |  |
| 798 | 1.4.1.4.1.10.2.1 | Programme Participants Ready to Start Connectivity Proving | milestone | 0d | 2023-11-24 A | 2023-11-24 A |  | 100% | 2023-11-24 | 2023-11-24 | 0d |  |  | start no earlier than 2023-11-24 |  | PP |  | 5.10 | Simon Berry | Systems Integration Testing (SIT) | Complete | COMPLETE |  |  |  |  |
| 799 | 1.4.1.4.1.10.2.2 | SIT Participants' SIT A environments ready to start connectivity proving CIT Interval 6 | milestone | 0d | 2023-11-24 A | 2023-11-24 A | 798 | 100% | 2023-11-24 | 2023-11-24 | 0d | 2023-11-24 | 2023-11-24 |  |  | PP | PP,IPA | 5.6 | Simon Berry | Systems Integration Testing (SIT) | Complete | COMPLETE | MHHS-ART139 | T3-TE-0024 | SITAG | T3 |
| 800 | 1.4.1.4.1.10.2.3 | Internal Connectivity Proving Phase |  | 10d | 2023-11-27 A | 2023-12-08 A | 799FS+1d | 100% | 2023-11-27 | 2023-12-08 | 10d |  |  |  |  | PP |  | 5.10 | Simon Berry | Systems Integration Testing (SIT) | Complete | COMPLETE |  |  |  |  |
| 801 | 1.4.1.4.1.10.2.4 | Internal Connectivity Proving Phase Complete | milestone | 0d | 2023-12-08 A | 2023-12-08 A | 800 | 100% | 2023-12-08 | 2023-12-08 | 0d |  |  |  |  | PP |  | 5.10 | Simon Berry | Systems Integration Testing (SIT) | Complete | COMPLETE |  |  |  |  |
| 802 | 1.4.1.4.1.10.2.5 | DIP Onboarding Activity (1. PKI Officers and Certificates, 2. Set-up Validation, 3. End Point Creation, 4. Controlled Smoke Test ) |  | 5d | 2023-12-04 A | 2023-12-08 A | 799FS+6d | 100% | 2023-12-04 | 2023-12-08 | 5d |  |  |  |  | PP |  | 5.10 | Simon Berry | Systems Integration Testing (SIT) | Complete | COMPLETE |  |  |  |  |
| 803 | 1.4.1.4.1.10.2.6 | DIP Onboarding Complete | milestone | 0d | 2023-12-08 A | 2023-12-08 A | 802 | 100% | 2023-12-08 | 2023-12-08 | 0d |  |  |  |  | PP |  | 5.10 | Simon Berry | Systems Integration Testing (SIT) | Complete | COMPLETE |  |  |  |  |
| 804 | 1.4.1.4.1.10.2.7 | PPs register PKI Officers and Request PKI Certificates Complete - Interval 6 | milestone | 0d | 2023-12-08 A | 2023-12-08 A | 803 | 100% | 2023-12-08 | 2023-12-08 | 0d | 2023-11-20 | 2023-11-24 | start no earlier than 2023-12-08 |  | PP | DIP Provider | 5.17 | Simon Berry | Systems Integration Testing (SIT) | Complete | COMPLETE |  | T3-TE-0102 | SITAG | T3 |
| 805 | 1.4.1.4.1.10.2.8 | PP Code Deployment | milestone | 0d | 2024-01-05 A | 2024-01-05 A |  | 100% | 2024-01-05 | 2024-01-05 | 0d |  |  | start no earlier than 2024-01-05 |  | PP |  | 5.10 | Simon Berry | Systems Integration Testing (SIT) | Complete | COMPLETE |  |  |  |  |

Notes:
- 781: 28/7: CH: added in to be aT3 milestone. 12/12 - Red because PPs required additional time due to some data changes required. No impact. Action to follow-up with PPs for latest progress / Action: 28/7: CH: Needs to be set-up as a reporting milestone. 31/7: Check with Cesar if has been approved so can be baselined
- 790: 2/1/24 - Approved at Dec TMAG following change in CIT governance
- 795: 9/1 - Not all completion reports yet received. Completed 22/2/24
- 799: 29/11 - Red because forecast date missed. Participants status to be determined by 4th December. No risk to future milestones
- 802: 5/12 -
- 804: 12/12 - Red because 1 Participant still to complete. 30/1 - Completed 29/1/24

| ID | WBS | Task | Type | Duration | Start | Finish | Predecessors | Complete | Remaining | Baseline start | Baseline finish | Baseline duration | Baseline 1 start | Baseline 1 finish | Total slack | Constraint | Baseline cost | Responsible | Involved | Update Version | MHHS Resource Name | MHHS Programme Phase | Sched Status | RAG | Artefact ID | Milestone ID | Text29 | Tier |
| --- | --- | --- | --- | --- | --- | --- | --- | --- | --- | --- | --- | --- | --- | --- | --- | --- | --- | --- | --- | --- | --- | --- | --- | --- | --- | --- | --- | --- |
| 806 | 1.4.1.4.1.10.3 | **Test Data (SIT A) Interval 6** |  | 25d | 2023-11-20 A | 2023-12-22 A |  | 100% |  | 2023-11-20 | 2023-12-22 | 25d | 2023-11-20 | 2023-12-22 |  |  |  | N/A | N/A | 5.0 | N/A | Systems Integration Testing (SIT) |  |  |  |  |  |  |
| 807 | 1.4.1.4.1.10.3.1 | Run data allocation |  | 10d | 2023-11-20 A | 2023-12-01 A | 777SS | 100% |  | 2023-11-20 | 2023-12-01 | 5d | 2023-11-20 | 2023-11-24 |  |  |  | SI Test |  | 5.0 | Richard Puddephatt | Systems Integration Testing (SIT) | Complete | COMPLETE |  |  |  |  |
| 808 | 1.4.1.4.1.10.3.2 | Cleanse and populate data post cut |  | 1d | 2023-12-04 A | 2023-12-04 A | 807 | 100% |  | 2023-12-04 | 2023-12-04 | 5d | 2023-11-27 | 2023-12-01 |  |  |  | SI Test |  | 5.0 | Richard Puddephatt | Systems Integration Testing (SIT) | Complete | COMPLETE |  |  |  |  |
| 809 | 1.4.1.4.1.10.3.3 | Transmit data sets to PPs |  | 1d | 2023-12-05 A | 2023-12-05 A | 808 | 100% |  | 2023-12-05 | 2023-12-05 | 2d | 2023-12-04 | 2023-12-05 |  |  |  | SI Test |  | 5.0 | Richard Puddephatt | Systems Integration Testing (SIT) | Complete | COMPLETE |  |  |  |  |
| 810 | 1.4.1.4.1.10.3.4 | PP - Load test data to test environments |  | 8d | 2023-12-06 A | 2023-12-15 A | 809 | 100% |  | 2023-12-06 | 2023-12-15 | 8d | 2023-12-06 | 2023-12-15 |  |  |  | PP |  | 5.0 | Richard Puddephatt | Systems Integration Testing (SIT) | Complete | COMPLETE |  |  |  |  |
| 811 | 1.4.1.4.1.10.3.5 | PP Check data integrity on test environment |  | 5d | 2023-12-18 A | 2023-12-22 A | 810 | 100% |  | 2023-12-18 | 2023-12-22 | 5d | 2023-12-18 | 2023-12-22 |  |  |  | PP |  | 5.0 | Richard Puddephatt | Systems Integration Testing (SIT) | Complete | COMPLETE |  |  |  |  |
| 812 | 1.4.1.4.1.10.3.6 | PP submit self-declaration to Programme to confirm loading & verification of test data | milestone | 0d | 2023-12-22 A | 2023-12-22 A | 811FF | 100% |  | 2023-12-22 | 2023-12-22 | 0d | 2023-12-22 | 2023-12-22 |  |  |  | PP | SI Test | 5.0 | Richard Puddephatt | Systems Integration Testing (SIT) | Complete | COMPLETE |  |  |  |  |
| 813 | 1.4.1.4.1.10.3.7 | Test Data (SIT A) Interval 6 Complete | milestone | 0d | 2023-12-22 A | 2023-12-22 A | 812 | 100% |  | 2023-12-22 | 2023-12-22 | 0d |  |  |  |  |  | SI Test | PP | 5.5 | Richard Puddephatt | Systems Integration Testing (SIT) | Complete | COMPLETE | MHHS-ART148/169 | T3-TE-0078 | SITAG | T3 |
| 814 | 1.4.1.4.1.10.4 | **Other Preparation** |  | 31d | 2023-12-04 A | 2024-01-15 A |  | 100% |  | 2023-12-04 | 2024-01-15 | 31d | 2023-09-04 | 2023-11-24 |  |  | -0 | N/A | N/A | 5.0 | N/A | Systems Integration Testing (SIT) |  |  |  |  |  |  |
| 815 | 1.4.1.4.1.10.4.1 | Onboarding of Test Participants to Test Management Tool (Azure DevOps) |  | 31d | 2023-12-04 A | 2024-01-15 A |  | 100% |  | 2023-12-04 | 2024-01-15 | 31d | 2023-09-04 | 2023-11-24 |  | start no earlier than 2023-12-04 |  | SI Test | PP | 5.0 | Simon Berry | Systems Integration Testing (SIT) | Complete | COMPLETE |  |  |  |  |
| 816 | 1.4.1.4.1.10.4.2 | Test Management Tool onboarding |  | 31d | 2023-12-04 A | 2024-01-15 A |  | 100% |  | 2023-12-04 | 2024-01-15 | 31d | 2023-09-04 | 2023-11-24 |  | start no earlier than 2023-12-04 |  | PP | SI Test | 5.0 | Simon Berry | Systems Integration Testing (SIT) | Complete | COMPLETE |  |  |  |  |
| 817 | 1.4.1.4.1.10.5 | **SIT Component Integration Test Readiness Report** |  | 25d | 2023-11-20 A | 2023-12-22 A |  | 100% |  | 2023-11-20 | 2023-12-22 | 25d | 2023-12-18 | 2024-01-19 |  |  |  | N/A | N/A | 5.0 | N/A | Systems Integration Testing (SIT) |  |  |  |  |  |  |
| 818 | 1.4.1.4.1.10.5.1 | PP submit Test Readiness Report to Programme for assurance | milestone | 0d | 2023-12-08 A | 2023-12-08 A | 610 | 100% |  | 2023-12-08 | 2023-12-08 | 0d | 2024-01-05 | 2024-01-05 |  |  |  | PP | SI Test | 5.0 |  | Systems Integration Testing (SIT) | Complete | COMPLETE |  |  |  |  |
| 819 | 1.4.1.4.1.10.5.2 | SI assure Test Participants' Test Readiness Reports |  | 5d | 2023-12-11 A | 2023-12-15 A | 818FF+5d | 100% |  | 2023-12-11 | 2023-12-15 | 5d | 2024-01-08 | 2024-01-12 |  |  |  | SI Test | PP,IPA | 5.0 |  | Systems Integration Testing (SIT) | Complete | COMPLETE |  |  |  |  |
| 820 | 1.4.1.4.1.10.5.3 | SI develop Overarching SIT Component Integration Test Readiness Report |  | 20d | 2023-11-20 A | 2023-12-15 A | 819FF | 100% |  | 2023-11-20 | 2023-12-15 | 20d | 2023-12-18 | 2024-01-12 |  |  |  | SI Test |  | 5.0 |  | Systems Integration Testing (SIT) | Complete | COMPLETE |  |  |  |  |
| 821 | 1.4.1.4.1.10.5.4 | Artefact review (via TMAG) and updates |  | 5d | 2023-12-18 A | 2023-12-22 A | 820 | 100% |  | 2023-12-18 | 2023-12-22 | 5d | 2024-01-15 | 2024-01-19 |  |  |  | SI Test | PP,IPA | 5.0 |  | Systems Integration Testing (SIT) | Complete | COMPLETE |  |  |  |  |
| 822 | 1.4.1.4.1.10.6 | SIT Component Integration Testing 6 Preparation Complete (incl. approval of SI SIT Component Integration Test Readiness Report) | milestone | 0d | 2024-01-19 A | 2024-01-19 A | 821FS+1d, 795, 799, 816, 818, 813, 282, 453 | 100% |  | 2024-01-19 | 2024-01-19 | 0d | 2024-01-22 | 2024-01-22 |  |  |  | SI Test | PP,IPA | 5.15 |  | Systems Integration Testing (SIT) | Complete | COMPLETE | MHHS-ART071 | T2-TE-0500 | SITAG | T2 |
| 823 | 1.4.1.4.2 | **SIT Functional Preparation** |  | 636d? | 2022-10-31 A | 2025-04-07 |  | 85% | 97.87d? | 2022-10-31 | 2025-04-07 | 520d | 2022-10-31 | 2024-03-01 | 708d |  | -0 | N/A | N/A | 5.0 | N/A | Systems Integration Testing (SIT) |  |  |  |  |  |  |
| 824 | 1.4.1.4.2.1 | Environment Approach and Plan - SIT Functional |  | 1d? | 2023-11-20 A | 2023-11-20 A |  | 100% |  | 2023-11-20 | 2023-11-20 | 0d |  |  |  | start no earlier than 2023-11-20 |  | SI Test |  | 6.0 |  |  | Complete | COMPLETE |  |  |  |  |
| 825 | 1.4.1.4.2.2 | **Test Approach & Plan** |  | 208d | 2022-10-31 A | 2023-08-16 A |  | 100% |  | 2022-10-31 | 2023-08-16 | 208d | 2022-10-31 | 2023-08-16 |  |  |  | N/A | N/A | 5.0 | N/A | Systems Integration Testing (SIT) |  |  |  |  |  |  |
| 826 | 1.4.1.4.2.2.1 | Develop document with SITWG |  | 179d | 2022-10-31 A | 2023-07-06 A |  | 100% |  | 2022-10-31 | 2023-07-06 | 179d | 2022-10-31 | 2023-07-06 |  | finish no earlier than 2023-07-06 |  | SI Test |  | 5.0 |  | Systems Integration Testing (SIT) | Complete | COMPLETE |  |  |  |  |
| 827 | 1.4.1.4.2.2.2 | Industry Consultation |  | 10d | 2023-07-07 A | 2023-07-20 A | 826 | 100% |  | 2023-07-07 | 2023-07-20 | 10d |  |  |  |  |  | PP |  | 5.1 |  | Systems Integration Testing (SIT) | Complete | COMPLETE |  |  |  |  |
| 828 | 1.4.1.4.2.2.3 | Artefact review (via TMAG) and updates |  | 19d | 2023-07-21 A | 2023-08-16 A | 827 | 100% |  | 2023-07-21 | 2023-08-16 | 19d | 2023-07-07 | 2023-08-03 |  | finish no earlier than 2023-08-03 |  | SI Test | PP,IPA,Code Bodies | 5.5 |  | Systems Integration Testing (SIT) | Complete | COMPLETE |  |  |  |  |
| 829 | 1.4.1.4.2.2.4 | SIT Functional Test Approach & Plan approved | milestone | 0d | 2023-08-16 A | 2023-08-16 A |  | 100% |  | 2023-08-16 | 2023-08-16 | 0d | 2023-08-16 | 2023-08-16 |  | finish no earlier than 2023-08-16 |  | SI Test | PP | 5.0 |  | Systems Integration Testing (SIT) | Complete | COMPLETE | MHHS-ART073 | T3-TE-0013 | SITAG | T3 |

Notes:
- 813: 28/7: CH: added in to be aT3 milestone / Action: 28/7: CH: Needs to be set-up as a reporting milestone. 31/7: Check with Cesar if has been approved so can be baselined
- 822: 2/1/24 - Approved at Dec TMAG following change in CIT governance

| ID | WBS | Task | Type | Duration | Start | Finish | Predecessors | Complete | Remaining | Baseline start | Baseline finish | Baseline duration | Baseline 1 start | Baseline 1 finish | Total slack | Free slack | Constraint | Baseline cost | Responsible | Involved | Update Version | MHHS Resource Name | MHHS Programme Phase | Sched Status | RAG | Artefact ID | Milestone ID | Text29 | Tier | Action | Guidance | Task Status |
| --- | --- | --- | --- | --- | --- | --- | --- | --- | --- | --- | --- | --- | --- | --- | --- | --- | --- | --- | --- | --- | --- | --- | --- | --- | --- | --- | --- | --- | --- | --- | --- | --- |
| 830 | 1.4.1.4.2.3 | **Test Data Approach & Plan** |  | 29d | 2023-07-07 A | 2023-08-16 A |  | 100% |  | 2023-07-07 | 2023-08-16 | 29d | 2023-07-07 | 2023-08-16 |  |  |  |  | N/A | N/A | 5.0 | N/A | Systems Integration Testing (SIT) |  |  |  |  |  |  |  |  |  |
| 831 | 1.4.1.4.2.3.1 | Industry Consultation |  | 10d | 2023-07-07 A | 2023-07-20 A | 827SS | 100% |  | 2023-07-07 | 2023-07-20 | 10d |  |  |  |  |  |  | PP |  | 5.1 | Cesar Lopes | Systems Integration Testing (SIT) | Complete | COMPLETE |  |  |  |  |  |  |  |
| 832 | 1.4.1.4.2.3.2 | Artefact review (via TMAG) and updates |  | 19d | 2023-07-21 A | 2023-08-16 A | 831 | 100% |  | 2023-07-21 | 2023-08-16 | 19d | 2023-07-07 | 2023-08-03 |  |  |  |  | SI Test |  | 5.5 | Cesar Lopes | Systems Integration Testing (SIT) | Complete | COMPLETE |  |  |  |  |  |  |  |
| 833 | 1.4.1.4.2.3.3 | SIT Functional Testing Test Data Approach & Plan approved | milestone | 0d | 2023-08-16 A | 2023-08-16 A | 832 | 100% |  | 2023-08-16 | 2023-08-16 | 0d | 2023-08-16 | 2023-08-16 |  |  |  |  | SI Test | PP,IPA | 5.5 | Cesar Lopes | Systems Integration Testing (SIT) | Complete | COMPLETE |  |  |  |  |  |  |  |
| 834 | 1.4.1.4.2.4 | **Test scenarios** |  | 298d | 2023-01-02 A | 2024-02-21 A |  | 100% |  | 2023-01-02 | 2024-02-21 | 298d | 2023-01-02 | 2023-06-02 |  |  |  | -0 | N/A | N/A | 5.0 | N/A | Systems Integration Testing (SIT) |  |  |  |  |  |  |  |  |  |
| 835 | 1.4.1.4.2.4.1 | Development of test scenarios |  | 85d | 2023-01-02 A | 2023-04-28 A | 826SS+45d | 100% |  | 2023-01-02 | 2023-04-28 | 85d | 2023-01-02 | 2023-04-28 |  |  |  |  | SI Test | PP, Code Bodies | 5.0 |  | Systems Integration Testing (SIT) | Complete | COMPLETE |  |  |  |  |  |  |  |
| 836 | 1.4.1.4.2.4.2 | Review test scenarios with SIT Working Group |  | 65d | 2023-08-17 A | 2023-11-15 A | 835FS+78d | 100% |  | 2023-08-17 | 2023-11-15 | 65d | 2023-02-01 | 2023-05-26 |  |  |  |  | SI Test | PP, Code Bodies, IPA | 5.0 |  | Systems Integration Testing (SIT) | Complete | COMPLETE |  |  |  |  |  |  |  |
| 837 | 1.4.1.4.2.4.3 | SIT Functional Testing Test scenarios (themes 1-5) approved | milestone | 0d | 2023-12-08 A | 2023-12-08 A | 836FS+17d | 100% |  | 2023-12-08 | 2023-12-08 | 0d | 2023-06-02 | 2023-06-02 |  |  |  |  | SI Test | PP | 5.14 |  | Systems Integration Testing (SIT) | Complete | COMPLETE | MMHS-ART073 | T3-TE-0015 | SITAG | T3 |  |  |  |
| 838 | 1.4.1.4.2.4.4 | SIT Functional Testing Test scenarios (themes 6,7,9) approved | milestone | 0d | 2024-01-17 A | 2024-01-17 A | 837FS+28d | 100% |  | 2024-01-17 | 2024-01-17 | 0d | 2023-06-02 | 2023-06-02 |  |  |  |  | SI Test | PP | 5.16 |  | Systems Integration Testing (SIT) | Complete | COMPLETE | MMHS-ART073 | T3-TE-0106 | SITAG | T3 |  |  |  |
| 839 | 1.4.1.4.2.4.5 | SIT Functional Testing Test scenarios (theme 8) approved | milestone | 0d | 2024-02-21 A | 2024-02-21 A | 838FS+25d | 100% |  | 2024-02-21 | 2024-02-21 | 0d | 2023-06-02 | 2023-06-02 |  |  |  |  | SI Test | PP | 5.14 |  | Systems Integration Testing (SIT) | Complete | COMPLETE | MMHS-ART073 | T3-TE-0107 | SITAG | T3 |  |  |  |
| 840 | 1.4.1.4.2.5 | **Test cases** |  | 465d? | 2023-05-01 A | 2025-02-07 |  | 84% | 75.81d? | 2023-05-01 | 2025-02-07 | 213d | 2023-05-01 | 2023-09-01 | 749d |  |  |  | N/A | N/A | 5.0 | N/A | Systems Integration Testing (SIT) |  |  |  |  |  |  | 25/7 - needs to be replanned |  |  |
| 841 | 1.4.1.4.2.5.1 | **SI Test cases** |  | 213d | 2023-05-01 A | 2024-02-21 A |  | 100% |  | 2023-05-01 | 2024-02-21 | 213d | 2023-05-01 | 2023-09-01 |  |  |  |  | N/A | N/A | 5.0 | N/A | Systems Integration Testing (SIT) |  |  |  |  |  |  | 25/7 - needs to be replanned |  |  |
| 842 | 1.4.1.4.2.5.1.1 | Development of Test cases |  | 150d | 2023-05-01 A | 2023-11-24 A | 835 | 100% |  | 2023-05-01 | 2023-11-24 | 150d | 2023-05-01 | 2023-07-28 |  |  |  |  | SI Test |  | 5.0 |  | Systems Integration Testing (SIT) | Complete | COMPLETE |  |  |  |  | 25/7 - needs to be replanned |  |  |
| 843 | 1.4.1.4.2.5.1.2 | Review Test cases with SIT Working Group |  | 78d | 2023-09-25 A | 2024-01-10 A | 842SS+105d | 100% |  | 2023-09-25 | 2024-01-10 | 78d | 2023-05-26 | 2023-08-25 |  |  |  |  | SI Test | PP,IPA | 5.0 |  | Systems Integration Testing (SIT) | Complete | COMPLETE |  |  |  |  | 25/7 - needs to be replanned |  |  |
| 844 | 1.4.1.4.2.5.1.3 | SIT Functional Testing Test Cases (themes 1-5) approved | milestone | 0d | 2024-01-17 A | 2024-01-17 A | 843FS+5d | 100% |  | 2024-01-17 | 2024-01-17 | 0d | 2023-09-01 | 2023-09-01 |  |  |  |  | SI Test | PP | 5.14 |  | Systems Integration Testing (SIT) | Complete | COMPLETE | MHHS-ART140 | T3-TE-0070 | SITAG | T3 |  | 2/1/24 - Approved at Dec TMAG |  |
| 845 | 1.4.1.4.2.5.1.4 | SIT Functional Testing Test cases (themes 6,7,9) approved | milestone | 0d | 2024-01-17 A | 2024-01-17 A | 844 | 100% |  | 2024-01-17 | 2024-01-17 | 0d | 2023-09-01 | 2023-09-01 |  |  |  |  | SI Test | PP | 5.14 |  | Systems Integration Testing (SIT) | Complete | COMPLETE | MHHS-ART140 | T3-TE-0108 | SITAG | T3 |  |  |  |
| 846 | 1.4.1.4.2.5.1.5 | SIT Functional Testing Test cases (theme 8) approved | milestone | 0d | 2024-02-21 A | 2024-02-21 A | 845FS+25d | 100% |  | 2024-02-21 | 2024-02-21 | 0d | 2023-09-01 | 2023-09-01 |  |  |  |  | SI Test | PP | 5.14 |  | Systems Integration Testing (SIT) | Complete | COMPLETE | MHHS-ART140 | T3-TE-0109 | SITAG | T3 |  |  |  |
| 847 | 1.4.1.4.2.5.2 | **SIT Functional Programme RTTM** |  | 55d? | 2024-07-29 A | 2024-10-11 |  | 95% | 2.95d? | 2024-07-29 | 2024-10-11 |  |  |  | 834d |  |  |  |  |  | 6.0 |  |  | Overdue Start | RED |  |  |  |  |  |  | -687.67 |
| 848 | 1.4.1.4.2.5.2.1 | **RTTM Development** |  | 40d? | 2024-07-29 A | 2024-09-20 |  | 99% | 0d? | 2024-07-29 | 2024-09-20 |  |  |  | 849d |  |  |  |  |  | 6.0 |  |  | Overdue Start | RED |  |  |  |  |  |  | -693.67 |
| 849 | 1.4.1.4.2.5.2.1.1 | Development of Manual SIT Functional RTTM |  | 30d? | 2024-07-29 A | 2024-09-06 A |  | 100% |  | 2024-07-29 | 2024-09-06 |  |  |  |  |  | start no earlier than 2024-07-29 |  |  |  | 6.0 |  |  | Complete | COMPLETE |  |  |  |  |  |  |  |
| 850 | 1.4.1.4.2.5.2.1.2 | Manual SIT Functional RTTM Complete | milestone | 0d? | 2024-09-06 A | 2024-09-06 A | 849 | 100% |  | 2024-09-06 | 2024-09-06 |  |  |  |  |  | start no earlier than 2024-07-29 |  |  |  | 6.0 |  |  | Complete | COMPLETE |  |  |  |  |  |  |  |
| 851 | 1.4.1.4.2.5.2.1.3 | Development of Automated SIT Functional RTTM |  | 40d? | 2024-07-29 A | 2024-09-20 A |  | 100% |  | 2024-07-29 | 2024-09-20 |  |  |  |  |  | start no earlier than 2024-07-29 |  |  |  | 6.0 |  |  | Complete | COMPLETE |  |  |  |  |  |  |  |
| 852 | 1.4.1.4.2.5.2.1.4 | Automated SIT Functional RTTM Complete | milestone | 0d? | 2024-09-20 A | 2024-09-20 | 851 | 80% | 0d? | 2024-09-20 | 2024-09-20 |  |  |  | 849d |  | finish no earlier than 2024-09-20 |  |  |  | 6.0 |  |  | Green | RED |  |  |  |  |  |  |  |
| 853 | 1.4.1.4.2.5.2.2 | **Gap analysis** |  | 35d? | 2024-08-26 A | 2024-10-11 |  | 86% | 5d? | 2024-08-26 | 2024-10-11 |  |  |  | 834d |  |  |  |  |  | 6.0 |  |  | Overdue Start | GREEN |  |  |  |  |  |  | -693.67 |
| 854 | 1.4.1.4.2.5.2.2.1 | Identify gaps in test case coverage following RTTM review. |  | 20d? | 2024-08-26 A | 2024-09-20 A | 851SS+20d | 100% |  | 2024-08-26 | 2024-09-20 |  |  |  |  |  |  |  |  |  | 6.0 |  |  | Complete | COMPLETE |  |  |  |  |  |  |  |
| 855 | 1.4.1.4.2.5.2.2.2 | Address gaps in test case coverage following RTTM review. |  | 20d | 2024-09-09 A | 2024-10-04 | 854SS+10d | 80% | 4d | 2024-09-09 | 2024-10-04 |  |  |  | 834d | 0d |  |  |  |  | 6.0 |  |  | Green | RED |  |  |  |  |  |  |  |
| 856 | 1.4.1.4.2.5.2.2.3 | SRO Walkthrough |  | 1d? | 2024-10-09 | 2024-10-09 | 855FS+2d |  |  | 2024-10-09 | 2024-10-09 |  |  |  | 836d |  |  |  |  |  | 6.0 |  |  | Green | RED |  |  |  |  |  |  | -8.67 |
| 857 | 1.4.1.4.2.5.2.2.4 | SRO Approval |  | 1d? | 2024-10-09 | 2024-10-09 | 855FS+2d |  |  | 2024-10-09 | 2024-10-09 |  |  |  | 834d | 0d |  |  |  |  | 6.0 |  |  | Green | RED |  |  |  |  |  |  | -8.67 |
| 858 | 1.4.1.4.2.5.2.2.5 | Gap analysis complete | milestone | 0d | 2024-10-11 | 2024-10-11 | 857FS+2d |  |  | 2024-10-11 | 2024-10-11 |  |  |  | 834d |  |  |  |  |  | 6.0 |  |  | Green | GREEN |  |  |  |  |  |  | -6.29 |

Notes:
- 837: Red because 8/12 TMAG moved to 20/12 due to reduction of Dec TMAGS. 5/12 Name change to SIT Functional Testing Test scenarios (themes 1-5) approved 20/12 - Approved at TMAG on 20/12
- 838: 5/12 - New milestone to go to 20/12 TMAG for approval. Added because of new delivery approach for SIT functional artifacts 20/12 - Approved at TMAG on 20/12
- 839: 5/12 - New milestone to go to 20/12 TMAG for approval. Added because of new delivery approach for SIT functional artifacts 20/12 - Approved at TMAG on 20/12
- 842: 15/9 - Potentially add in additional lines to track against progress
- 844: 5/12 Name change to SIT Functional Testing Test Cases (themes 1-5) approved 20/12 - Approved at TMAG on 20/12
- 845: 5/12- New milestone added because revised delivery approach for SIT Functional 20/12 - Approved at TMAG on 20/12
- 846: 5/12- New milestone added because revised delivery approach for SIT Functional

| ID | WBS | Task | Duration | Start | Finish | Predecessors | Complete | Remaining | Baseline start | Baseline finish | Total slack | Free slack | Constraint | Task Status | Update Version | Sched Status | RAG |
| --- | --- | --- | --- | --- | --- | --- | --- | --- | --- | --- | --- | --- | --- | --- | --- | --- | --- |
| 859 | 1.4.1.4.2.5.3 | **Cycle 3 Test Evidence Capturing Approach** | 25d? | 2024-09-16 A | 2024-10-18 |  | 93% | 1.88d? | 2024-09-16 | 2024-10-18 | 3d |  |  | -692.67 | 6.0 | Overdue Start | GREEN |
| 860 | 1.4.1.4.2.5.3.1 | Define guiding principles and proof of concept | 10d | 2024-09-16 A | 2024-09-27 A |  | 100% |  | 2024-09-16 | 2024-09-27 |  |  | start no earlier than 2024-09-16 |  | 6.0 | Complete | COMPLETE |
| 861 | 1.4.1.4.2.5.3.2 | Draft proposed test evidence capturing approach | 3d | 2024-09-30 A | 2024-10-02 A | 860 | 100% |  | 2024-09-30 | 2024-10-02 |  |  |  |  | 6.0 | Complete | COMPLETE |
| 862 | 1.4.1.4.2.5.3.3 | SRO review | 5d | 2024-10-03 A | 2024-10-09 A | 861 | 100% |  | 2024-10-03 | 2024-10-09 |  |  |  |  | 6.0 | Complete | COMPLETE |
| 863 | 1.4.1.4.2.5.3.4 | Present proposed approach | 1d? | 2024-10-11 A | 2024-10-11 A | 862FS+1d | 100% |  | 2024-10-11 | 2024-10-11 |  |  |  |  | 6.0 | Complete | COMPLETE |
| 864 | 1.4.1.4.2.5.3.5 | Incorporate feedback | 4d | 2024-10-14 A | 2024-10-17 | 863 | 80% | 0.8d | 2024-10-14 | 2024-10-17 | 3d | 0d |  |  | 6.0 | Green | GREEN |
| 865 | 1.4.1.4.2.5.3.6 | Publish proposed approach ahead of Cycle 3 start | 1d? | 2024-10-18 | 2024-10-18 | 864 |  |  | 2024-10-18 | 2024-10-18 | 3d | 0d |  | 0.33 | 6.0 | Green | GREEN |
| 866 | 1.4.1.4.2.5.4 | **DITL Cycle 3 Pack Development** | 8d? | 2024-10-08 A | 2024-10-17 |  | 31% | 5.5d? | 2024-10-08 | 2024-10-17 | 830d |  |  | 6.33 | 6.0 | No BL | GREEN |
| 867 | 1.4.1.4.2.5.4.1 | Programme Cycle 2 Retro | 1d? | 2024-10-08 A | 2024-10-08 A |  | 100% |  | 2024-10-08 | 2024-10-08 |  |  | start no earlier than 2024-10-08 |  | 6.0 | Complete | COMPLETE |
| 868 | 1.4.1.4.2.5.4.2 | Post-retro DITL Changes | 3d | 2024-10-09 A | 2024-10-11 | 867 | 50% | 1.5d | 2024-10-09 | 2024-10-11 | 830d | 0d |  |  | 6.0 | Green | RED |
| 869 | 1.4.1.4.2.5.4.3 | SRO Review | 2d | 2024-10-14 | 2024-10-15 | 868 |  |  | 2024-10-14 | 2024-10-15 | 830d | 0d |  | -3.67 | 6.0 | Green | AMBER |
| 870 | 1.4.1.4.2.5.4.4 | Post-SRO Review Changes | 1d? | 2024-10-16 | 2024-10-16 | 869 |  |  | 2024-10-16 | 2024-10-16 | 830d | 0d |  | -1.67 | 6.0 | Green | AMBER |
| 871 | 1.4.1.4.2.5.4.5 | Publish Cycle 3 DITL / Cycle 3 DITL Online Sessions for SIT PPs | 1d? | 2024-10-17 | 2024-10-17 | 870 |  |  | 2024-10-17 | 2024-10-17 | 830d |  |  | -0.67 | 6.0 | Green | AMBER |
| 872 | 1.4.1.4.2.5.5 | **Test Script Exit Points** | 85d | 2024-10-14 A | 2025-02-07 |  | 7% | 79.33d | 2024-10-14 | 2025-02-07 | 749d |  |  | -694.67 | 6.0 | Overdue Start | GREEN |
| 873 | 1.4.1.4.2.5.5.1 | Identify exit points for Sprint 5 | 5d | 2024-10-14 A | 2024-10-18 | 865FS-5d | 60% | 2d | 2024-10-14 | 2024-10-18 | 829d |  |  |  | 6.0 | Green | GREEN |
| 874 | 1.4.1.4.2.5.5.2 | Identify exit points for Sprint 6 | 5d | 2024-10-21 | 2024-10-25 | 1255SS |  |  | 2024-10-21 | 2024-10-25 | 824d |  |  | 3.33 | 6.0 | Green | GREEN |
| 875 | 1.4.1.4.2.5.5.3 | Identify exit points for Sprint 7 | 5d | 2024-11-04 | 2024-11-08 | 1256SS |  |  | 2024-11-04 | 2024-11-08 | 814d |  |  | 17.33 | 6.0 | Green | GREEN |
| 876 | 1.4.1.4.2.5.5.4 | Identify exit points for Sprint 8 | 5d | 2024-11-18 | 2024-11-22 | 1257SS |  |  | 2024-11-18 | 2024-11-22 | 804d |  |  | 31.33 | 6.0 | Green | GREEN |
| 877 | 1.4.1.4.2.5.5.5 | Identify exit points for Sprint 9 | 5d | 2024-12-02 | 2024-12-06 | 1258SS |  |  | 2024-12-02 | 2024-12-06 | 794d |  |  | 45.33 | 6.0 | Green | GREEN |
| 878 | 1.4.1.4.2.5.5.6 | Identify exit points for Sprint 10 | 5d | 2024-12-23 | 2024-12-27 | 1259SS |  |  | 2024-12-23 | 2024-12-27 | 779d |  |  | 66.33 | 6.0 | Green | GREEN |
| 879 | 1.4.1.4.2.5.5.7 | Identify exit points for Sprint 11 | 5d | 2025-01-06 | 2025-01-10 | 1260SS |  |  | 2025-01-06 | 2025-01-10 | 769d |  |  | 80.33 | 6.0 | Green | GREEN |
| 880 | 1.4.1.4.2.5.5.8 | Identify exit points for Sprint 12 | 5d | 2025-01-20 | 2025-01-24 | 1261SS |  |  | 2025-01-20 | 2025-01-24 | 759d |  |  | 94.33 | 6.0 | Green | GREEN |
| 881 | 1.4.1.4.2.5.5.9 | Identify exit points for Sprint 13 | 5d | 2025-02-03 | 2025-02-07 | 1262SS |  |  | 2025-02-03 | 2025-02-07 | 749d |  |  | 108.33 | 6.0 | Green | GREEN |
| 882 | 1.4.1.4.2.5.6 | **Cycle 3 Test Case Rationalisation (Functional and Migration)** | 36d? | 2024-09-16 A | 2024-11-04 |  | 59% | 14.82d? | 2024-09-16 | 2024-11-04 | 818d |  |  | -692.67 | 6.0 | Overdue Start | GREEN |
| 883 | 1.4.1.4.2.5.6.1 | Review Cycle 3 scope and identify candidates for rationalisation | 25d | 2024-09-16 A | 2024-10-18 |  | 60% | 10d | 2024-09-16 | 2024-10-18 | 829d |  | start no earlier than 2024-09-16 |  | 6.0 | Green | GREEN |
| 884 | 1.4.1.4.2.5.6.2 | Define proposal for rationalisation of test cases | 15d | 2024-09-30 A | 2024-10-18 A | 883 | 100% |  | 2024-09-30 | 2024-10-18 |  |  |  |  | 6.0 | Complete | COMPLETE |
| 885 | 1.4.1.4.2.5.6.3 | SRO review | 5d | 2024-10-21 | 2024-10-25 | 884 |  |  | 2024-10-21 | 2024-10-25 | 818d | 0d |  | 3.33 | 6.0 | Green | GREEN |
| 886 | 1.4.1.4.2.5.6.4 | Present proposed approach | 1d? | 2024-10-28 | 2024-10-28 | 885 |  |  | 2024-10-28 | 2024-10-28 | 818d | 0d |  | 10.33 | 6.0 | Green | GREEN |
| 887 | 1.4.1.4.2.5.6.5 | Incorporate feedback | 4d | 2024-10-29 | 2024-11-01 | 886 |  |  | 2024-10-29 | 2024-11-01 | 818d | 0d |  | 11.33 | 6.0 | Green | GREEN |
| 888 | 1.4.1.4.2.5.6.6 | Publish proposed approach ahead of Cycle 3 start | 1d? | 2024-11-04 | 2024-11-04 | 887 |  |  | 2024-11-04 | 2024-11-04 | 818d |  |  | 17.33 | 6.0 | Green | GREEN |

| ID | WBS | Task | Type | Duration | Start | Finish | Predecessors | Complete | Remaining | Baseline start | Baseline finish | Baseline duration | Baseline 1 start | Baseline 1 finish | Total slack | Constraint | Baseline cost | Responsible | Involved | Update Version | MHHS Resource Name | MHHS Programme Phase | Task Status | Sched Status | RAG | Action | Milestone ID | Text29 | Tier | Artefact ID |
| --- | --- | --- | --- | --- | --- | --- | --- | --- | --- | --- | --- | --- | --- | --- | --- | --- | --- | --- | --- | --- | --- | --- | --- | --- | --- | --- | --- | --- | --- | --- |
| 889 | 1.4.1.4.2.6 | **Environments (SIT-Staging)** |  | 10d | 2023-12-04 A | 2023-12-15 A |  | 100% |  | 2023-12-04 | 2023-12-15 | 323d | 2022-11-16 | 2024-02-09 |  |  |  | N/A | N/A | 5.0 | N/A | Systems Integration Testing (SIT) |  |  |  |  |  |  |  |  |
| 890 | 1.4.1.4.2.6.1 | **SIT Functional pre-requisites** |  | 10d | 2023-12-04 A | 2023-12-15 A |  | 100% |  | 2023-12-04 | 2023-12-15 | 10d |  |  |  |  |  | N/A | N/A | 5.3 | N/A | Systems Integration Testing (SIT) |  |  |  |  |  |  |  |  |
| 891 | 1.4.1.4.2.6.1.1 | **DCC** |  | 10d | 2023-12-04 A | 2023-12-15 A |  | 100% |  | 2023-12-04 | 2023-12-15 | 10d |  |  |  |  |  | N/A | N/A | 5.3 | N/A | Systems Integration Testing (SIT) | -254.67 |  |  |  |  |  |  |  |
| 892 | 1.4.1.4.2.6.1.1.1 | **CSS** |  | 10d | 2023-12-04 A | 2023-12-15 A |  | 100% |  | 2023-12-04 | 2023-12-15 | 10d |  |  |  |  |  | N/A | N/A | 5.3 | N/A | Systems Integration Testing (SIT) | -254.67 |  |  |  |  |  |  |  |
| 893 | 1.4.1.4.2.6.1.1.1.1 | SIT participants have requested DCC CSS PKI certificates for access to UIT-B environment |  | 10d | 2023-12-04 A | 2023-12-15 A |  | 100% |  | 2023-12-04 | 2023-12-15 | 10d |  |  |  | start no earlier than 2023-12-04 |  | SIT Participants (Suppliers & Third Parties) | PP | 5.3 | Simon Berry | Systems Integration Testing (SIT) |  | Complete | COMPLETE |  |  |  |  |  |
| 894 | 1.4.1.4.2.6.1.1.1.2 | SIT participants have received DCC CSS PKI certificates for UIT-B environment | milestone | 0d | 2023-12-15 A | 2023-12-15 A | 893 | 100% |  | 2023-12-15 | 2023-12-15 | 0d |  |  |  |  |  | SIT Participants (Suppliers & Third Parties) | PP | 5.5 | Simon Berry | Systems Integration Testing (SIT) |  | Complete | COMPLETE | 7/8 - added as a T3 milestone. Awaiting approval at TMAG | T3-TE-0088 | SITAG | T3 |  |
| 895 | 1.4.1.4.2.6.1.1.2 | **DSP** |  | 10d | 2023-12-04 A | 2023-12-15 A |  | 100% |  | 2023-12-04 | 2023-12-15 | 10d |  |  |  |  |  | N/A | N/A | 5.3 | N/A | Systems Integration Testing (SIT) | -254.67 |  |  |  |  |  |  |  |
| 896 | 1.4.1.4.2.6.1.1.2.1 | SIT participants have requested DCC DSP PKI certificates for access to UIT-B environment |  | 10d | 2023-12-04 A | 2023-12-15 A |  | 100% |  | 2023-12-04 | 2023-12-15 | 10d |  |  |  | start no earlier than 2023-12-04 |  | PPs in SDS Market Role | PP | 5.3 | Simon Berry | Systems Integration Testing (SIT) |  | Complete | COMPLETE |  |  |  |  |  |
| 897 | 1.4.1.4.2.6.1.1.2.2 | SIT participants have received DCC DSP PKI certificates for UIT-B environment | milestone | 0d | 2023-12-15 A | 2023-12-15 A | 896 | 100% |  | 2023-12-15 | 2023-12-15 | 0d |  |  |  |  |  | PPs in SDS Market Role | PP | 5.5 | Simon Berry | Systems Integration Testing (SIT) |  | Complete | COMPLETE | 7/8 - added as a T3 milestone. Awaiting approval at TMAG | T3-TE-0089 | SITAG | T3 |  |
| 898 | 1.4.1.4.2.7 | **Stand up SIT A Environment** |  | 25d | 2024-02-05 A | 2024-03-08 A |  | 100% |  | 2024-02-05 | 2024-03-08 | 25d | 2024-02-05 | 2024-02-09 |  |  |  | N/A | N/A | 6.0 | N/A | Systems Integration Testing (SIT) |  |  |  |  |  |  |  |  |
| 899 | 1.4.1.4.2.7.1 | **SIT Functional Connectivity Proving** |  | 15d | 2024-02-12 A | 2024-03-01 A |  | 100% |  | 2024-02-12 | 2024-03-01 | 20d |  |  |  |  |  | N/A | N/A | 5.5 | N/A | Systems Integration Testing (SIT) | -288.67 |  |  |  |  |  |  |  |
| 900 | 1.4.1.4.2.7.1.1 | SIT Functional Connectivity Proving Period |  | 15d | 2024-02-12 A | 2024-03-01 A |  | 100% |  | 2024-02-12 | 2024-03-01 | 20d |  |  |  | start no earlier than 2024-01-08 |  | SI Test | PP | 5.19 | Simon Berry | Systems Integration Testing (SIT) |  | Complete | COMPLETE |  |  |  |  |  |
| 901 | 1.4.1.4.2.7.1.2 | SIT Functional Connectivity Proving Complete | milestone | 0d | 2024-03-01 A | 2024-03-01 A | 900 | 100% |  | 2024-03-01 | 2024-03-01 | 0d |  |  |  | start no earlier than 2024-03-01 |  | SI Test | PP | 5.19 | Simon Berry | Systems Integration Testing (SIT) |  | Complete | COMPLETE |  | T3-TE-0103 | SITAG | T3 |  |
| 902 | 1.4.1.4.2.7.2 | **PP Environments (SIT A)** |  | 25d | 2024-02-05 A | 2024-03-08 A |  | 100% |  | 2024-02-05 | 2024-03-08 | 5d | 2024-02-05 | 2024-02-09 |  |  |  | N/A | N/A | 5.0 | N/A | Systems Integration Testing (SIT) |  |  |  |  |  |  |  |  |
| 903 | 1.4.1.4.2.7.2.1 | Deployment of MHHS solution code to SIT A environments |  | 25d | 2024-02-05 A | 2024-03-08 A |  | 100% |  | 2024-02-05 | 2024-03-08 | 5d | 2024-02-05 | 2024-02-09 |  | start no earlier than 2024-02-05 |  | PP | SI Test | 5.0 | Simon Berry | Systems Integration Testing (SIT) |  | Complete | COMPLETE |  |  |  |  |  |
| 904 | 1.4.1.4.2.7.3 | **SI Environments (SIT A)** |  | 25d | 2024-02-05 A | 2024-03-08 A |  | 100% |  | 2024-02-05 | 2024-03-08 | 5d | 2024-02-05 | 2024-02-09 |  |  |  | N/A | N/A | 5.0 | N/A | Systems Integration Testing (SIT) |  |  |  |  |  |  |  |  |
| 905 | 1.4.1.4.2.7.3.1 | Coordinate deployment of MHHS solution code to SIT Participants' SIT A environments |  | 25d | 2024-02-05 A | 2024-03-08 A | 903SS | 100% |  | 2024-02-05 | 2024-03-08 | 5d | 2024-02-05 | 2024-02-09 |  |  |  | SI Test | PP | 5.0 | Simon Berry | Systems Integration Testing (SIT) |  | Complete | COMPLETE |  |  |  |  |  |
| 906 | 1.4.1.4.2.8 | **Test data (SIT A)** |  | 341d? | 2023-12-18 A | 2025-04-07 |  | 57% | 147.28d? | 2023-12-18 | 2025-04-07 | 225d |  |  | 708d |  | -0 | N/A | N/A | 5.4 | N/A | Systems Integration Testing (SIT) | -269.67 |  |  |  |  |  |  |  |
| 907 | 1.4.1.4.2.8.1 | **Cycle 1 Test data (SIT A)** |  | 55d | 2023-12-18 A | 2024-03-01 A |  | 100% |  | 2023-12-18 | 2024-03-01 | 55d |  |  |  |  | -0 | N/A | N/A | 5.4 | N/A | Systems Integration Testing (SIT) | -269.67 |  |  |  |  |  |  |  |
| 908 | 1.4.1.4.2.8.1.1 | Prepare, Generate and Allocate Test Data |  | 28d | 2023-12-18 A | 2024-01-24 A | 642, 650 | 100% |  | 2023-12-18 | 2024-01-24 | 28d |  |  |  | start no earlier than 2023-12-11 |  | SI Test Data |  | 5.14 | Richard Puddephatt | Systems Integration Testing (SIT) |  | Complete | COMPLETE |  |  |  |  |  |
| 909 | 1.4.1.4.2.8.1.2 | Transmit Data Sets to PPs |  | 4d | 2024-01-26 A | 2024-01-31 A | 908FS+1d | 100% |  | 2024-01-26 | 2024-01-31 | 2d |  |  |  |  |  | SI Test Data |  | 5.14 | Richard Puddephatt | Systems Integration Testing (SIT) |  | Complete | COMPLETE |  |  |  |  |  |
| 910 | 1.4.1.4.2.8.1.3 | PP's Iterative load and data integrity check |  | 22d | 2024-02-01 A | 2024-03-01 A | 909 | 100% |  | 2024-02-01 | 2024-03-01 | 10d |  |  |  |  |  | PP |  | 5.14 | Richard Puddephatt | Systems Integration Testing (SIT) |  | Complete | COMPLETE |  |  |  |  |  |
| 911 | 1.4.1.4.2.8.1.4 | Cycle 1 - PP's confirmation that test data is ready for SIT Functional | milestone | 0d | 2024-03-01 A | 2024-03-01 A | 910 | 100% |  | 2024-03-01 | 2024-03-01 | 0d |  |  |  |  |  | SI Test Data |  | 5.18 | Richard Puddephatt | Systems Integration Testing (SIT) |  | Complete | COMPLETE | 2/8 - added as a T3 milestone. Awaiting approval at TMAG | T3-TE-0079 | SITAG | T3 | MHHS-ART140 MHHS-ART169 |
| 912 | 1.4.1.4.2.8.2 | **Cycle 2 Test data (inc. Settlement Data) (SIT A)** |  | 57d | 2024-03-28 A | 2024-06-14 A |  | 100% |  | 2024-03-28 | 2024-06-14 | 47d |  |  |  |  | -0 | N/A | N/A | 6.0 | N/A | Systems Integration Testing (SIT) |  |  |  |  |  |  |  |  |
| 913 | 1.4.1.4.2.8.2.1 | Prepare, Generate and Allocate Test Data |  | 31d | 2024-03-28 A | 2024-05-09 A | 911FS+18d | 100% |  | 2024-03-28 | 2024-05-09 | 31d |  |  |  |  |  | SI Test Data |  | 5.14 | Richard Puddephatt | Systems Integration Testing (SIT) |  | Complete | COMPLETE |  |  |  |  |  |
| 914 | 1.4.1.4.2.8.2.2 | Transmit Data Sets to PPs |  | 3d | 2024-05-10 A | 2024-05-14 A | 913 | 100% |  | 2024-05-10 | 2024-05-14 | 3d |  |  |  |  |  | SI Test Data |  | 5.14 | Richard Puddephatt | Systems Integration Testing (SIT) |  | Complete | COMPLETE |  |  |  |  |  |
| 915 | 1.4.1.4.2.8.2.3 | PP's Iterative load and data integrity check |  | 13d | 2024-05-15 A | 2024-05-31 A | 914 | 100% |  | 2024-05-15 | 2024-05-31 | 13d |  |  |  |  |  | PP |  | 5.14 | Richard Puddephatt | Systems Integration Testing (SIT) |  | Complete | COMPLETE |  |  |  |  |  |
| 916 | 1.4.1.4.2.8.2.4 | Cycle 2 - PP's confirmation that test data is ready for SIT Functional | milestone | 0d | 2024-06-14 A | 2024-06-14 A | 915FS+10d | 100% |  | 2024-06-14 | 2024-06-14 | 0d |  |  |  |  |  | SI Test Data |  | 5.27 | Richard Puddephatt | Systems Integration Testing (SIT) |  | Complete | COMPLETE | 2/8 - added as a T3 milestone. Awaiting approval at TMAG | T3-TE-0080 | SITAG | T3 | MHHS-ART140 MHHS-ART169 |

Notes:
- 894: To be proposed as a T3 Milestone at next TMAG
- 897: 19/12 - MHHS PPs who require DCC, DSP, PKI certificates will request them in order to participate in DCC UEPT
- 898: 12/09/24 - Name change in line with SI Plan
- 900: 16/8 - Needs to start 8 weeks before SIT Functional Testing starts
- 901: 21/2/24 - Date change approved at SITAG on 21/2/24. 4/3 - PPs in the process of completing the activity, two thirds complete, the remain under in various stages of completeness
- 911: 21/2/24 - Date change approved at SITAG on 21/2/24. 5/3 - Red because 20% of PPs differed the data load to 6/3. These PPs have an action plan to complete this.
- 912: 12/09/24 - Name change in line with the SI Plan
- 916: 4/6: Date missed because there are 3 separate data loads for each PP to complete. This is proving time consuming but is expected to complete by 14/6

| ID | WBS | Task | Type | Duration | Start | Finish | Predecessors | Complete | Remaining | Baseline start | Baseline finish | Baseline duration | Total slack | Free slack | Constraint | Baseline cost | Responsible | Involved | Update Version | Sched Status | MHHS Resource Name | MHHS Programme Phase | RAG | Text29 | Task Status | Milestone ID | Artefact ID | Action | Tier |
| --- | --- | --- | --- | --- | --- | --- | --- | --- | --- | --- | --- | --- | --- | --- | --- | --- | --- | --- | --- | --- | --- | --- | --- | --- | --- | --- | --- | --- | --- |
| 917 | 1.4.1.4.2.8.3 | **Cycle 3 Test data (SIT A) (2)** |  | 71d? | 2024-07-15 A | 2024-10-21 |  | 80% | 14.53d? | 2024-07-15 | 2024-10-21 | 41d | 828d |  |  | -0 | N/A | N/A | 5.4 | Overdue | N/A | Systems Integration Testing (SIT) | GREEN |  |  |  |  |  |  |
| 918 | 1.4.1.4.2.8.3.1 | Cycle 3 data requirments analysis - check Cycle 2 data for gaps Check blocked test cases |  | 10d? | 2024-07-15 A | 2024-07-26 A |  | 100% |  | 2024-07-15 | 2024-07-26 |  |  |  | finish no earlier than 2024-07-26 |  |  |  | 6.0 | Complete | Richard Puddephatt |  | COMPLETE | SITAG |  |  |  |  |  |
| 919 | 1.4.1.4.2.8.3.2 | Provide DCC with MPANS for deletion secure file with password |  | 1d? | 2024-08-12 A | 2024-08-12 A |  | 100% |  | 2024-08-12 | 2024-08-12 |  |  |  |  |  |  |  | 6.0 | Complete | Richard Puddephatt |  | COMPLETE |  |  |  |  |  |  |
| 920 | 1.4.1.4.2.8.3.3 | Receive MPANS from DCC to exclude |  | 1d? | 2024-08-09 A | 2024-08-09 A |  | 100% |  | 2024-08-09 | 2024-08-09 |  |  |  |  |  |  |  | 6.0 | Complete | Richard Puddephatt |  | COMPLETE |  |  |  |  |  |  |
| 921 | 1.4.1.4.2.8.3.4 | Exclude MPANS from allocation |  | 1d | 2024-08-16 A | 2024-08-16 A |  | 100% |  | 2024-08-16 | 2024-08-16 |  |  |  |  |  |  |  | 6.0 | Complete | Richard Puddephatt |  | COMPLETE |  |  |  |  |  |  |
| 922 | 1.4.1.4.2.8.3.5 | Allocate Cycle 3 MPANS |  | 16d? | 2024-08-06 A | 2024-08-27 A |  | 100% |  | 2024-08-06 | 2024-08-27 |  |  |  |  |  |  |  | 6.0 | Complete | Richard Puddephatt |  | COMPLETE |  |  |  |  |  |  |
| 923 | 1.4.1.4.2.8.3.6 | Generate Cycle 3 Data |  | 2d? | 2024-08-27 A | 2024-08-28 A |  | 100% |  | 2024-08-27 | 2024-08-28 |  |  |  |  |  |  |  | 6.0 | Complete | Richard Puddephatt |  | COMPLETE |  |  |  |  |  |  |
| 924 | 1.4.1.4.2.8.3.7 | Check data prior to sending to DCC |  | 5d? | 2024-08-22 A | 2024-08-28 A |  | 100% |  | 2024-08-22 | 2024-08-28 |  |  |  |  |  |  |  | 6.0 | Complete | Richard Puddephatt |  | COMPLETE |  |  |  |  |  |  |
| 925 | 1.4.1.4.2.8.3.8 | Share Cycle 3 MPAN data with DCC |  | 1d? | 2024-08-29 A | 2024-08-29 A |  | 100% |  | 2024-08-29 | 2024-08-29 |  |  |  |  |  |  |  | 6.0 | Complete | Richard Puddephatt |  | COMPLETE |  |  |  |  |  |  |
| 926 | 1.4.1.4.2.8.3.9 | DCC - load data and create registration Id's for Cycle 3 data |  | 13d? | 2024-08-27 A | 2024-09-12 A |  | 100% |  | 2024-08-27 | 2024-09-12 |  |  |  |  |  |  |  | 6.0 | Complete | Richard Puddephatt |  | COMPLETE |  |  |  |  |  |  |
| 927 | 1.4.1.4.2.8.3.10 | Add registration ID's to Cycle 3 Data |  | 2d? | 2024-09-12 A | 2024-09-13 A |  | 100% |  | 2024-09-12 | 2024-09-13 |  |  |  |  |  |  |  | 6.0 | Complete | Richard Puddephatt |  | COMPLETE |  |  |  |  |  |  |
| 928 | 1.4.1.4.2.8.3.11 | Share subset of data with St Cls for data load |  | 2d? | 2024-09-12 A | 2024-09-13 A |  | 100% |  | 2024-09-12 | 2024-09-13 |  |  |  |  |  |  |  | 6.0 | Complete | Richard Puddephatt |  | COMPLETE |  |  |  |  |  |  |
| 929 | 1.4.1.4.2.8.3.12 | St Clements to run test with Subset of data - MPRS business process checks including Import/Export MPANS |  | 5d? | 2024-09-16 A | 2024-09-20 A |  | 100% |  | 2024-09-16 | 2024-09-20 |  |  |  |  |  |  |  | 6.0 | Complete | Richard Puddephatt |  | COMPLETE |  |  |  |  |  |  |
| 930 | 1.4.1.4.2.8.3.13 | Send Cycle 3 data to partcipants for early sight of data |  | 3d? | 2024-09-25 A | 2024-09-27 A |  | 100% |  | 2024-09-25 | 2024-09-27 |  |  |  |  |  |  |  | 6.0 | Complete | Richard Puddephatt |  | COMPLETE |  |  |  |  |  |  |
| 931 | 1.4.1.4.2.8.3.14 | St Clements MPRS data load bulk files for Cycle 3 |  | 15d? | 2024-09-23 A | 2024-10-11 A |  | 100% |  | 2024-09-23 | 2024-10-11 |  |  |  |  |  |  |  | 6.0 | Complete | Richard Puddephatt |  | COMPLETE |  |  |  |  |  |  |
| 932 | 1.4.1.4.2.8.3.15 | New MPAN creation and load through DCC and St Clements |  | 1d? | 2024-10-11 A | 2024-10-11 |  | 95% | 0.05d? | 2024-10-11 | 2024-10-11 |  | 834d |  | start no earlier than 2024-10-11 |  |  |  | 6.0 | Green | Richard Puddephatt |  | GREEN |  |  |  |  |  |  |
| 933 | 1.4.1.4.2.8.3.16 | Share files with PP's and central parties |  | 1d | 2024-10-11 | 2024-10-11 |  |  |  | 2024-10-11 | 2024-10-11 |  | 834d |  | start no earlier than 2024-10-11 |  |  |  | 6.0 | Green | Richard Puddephatt |  | GREEN |  | -6.67 |  |  |  |  |
| 934 | 1.4.1.4.2.8.3.17 | Avanade to load data |  | 6d | 2024-10-14 | 2024-10-21 |  |  |  | 2024-10-14 | 2024-10-21 |  | 828d |  | start no earlier than 2024-10-14 |  |  |  | 6.0 | Green | Richard Puddephatt |  | GREEN |  | -3.67 |  |  |  |  |
| 935 | 1.4.1.4.2.8.3.18 | Helix to load data |  | 6d | 2024-10-14 | 2024-10-21 |  |  |  | 2024-10-14 | 2024-10-21 |  | 828d |  | start no earlier than 2024-10-14 |  |  |  | 6.0 | Green | Richard Puddephatt |  | GREEN |  | -3.67 |  |  |  |  |
| 936 | 1.4.1.4.2.8.3.19 | PP's and central parties to load all Cycle 3 data |  | 6d | 2024-10-14 | 2024-10-21 |  |  |  | 2024-10-14 | 2024-10-21 |  | 828d |  | start no earlier than 2024-10-14 |  |  |  | 6.0 | Green | Richard Puddephatt |  | GREEN |  | -3.67 |  |  |  |  |
| 937 | 1.4.1.4.2.8.3.20 | All parties to finalise data load |  | 1d? | 2024-10-21 | 2024-10-21 |  |  |  | 2024-10-21 | 2024-10-21 |  | 34d | 0d | start no earlier than 2024-10-21 |  |  |  | 6.0 | Green | Richard Puddephatt |  | GREEN |  | 3.33 | T3-TE-0081 |  |  |  |
| 938 | 1.4.1.4.2.8.4 | **Regression Test data (SIT A)** |  | 116d | 2024-10-28 | 2025-04-07 |  |  |  | 2024-10-28 | 2025-04-07 | 45d | 34d |  |  | -0 | N/A | N/A | 5.4 |  | N/A | Systems Integration Testing (SIT) | GREEN |  |  |  |  |  |  |
| 939 | 1.4.1.4.2.8.4.1 | Prepare, Generate and Allocate Test Data |  | 94d | 2024-10-28 | 2025-03-06 | 937FS+4d |  |  | 2024-10-28 | 2025-03-06 | 23d | 34d | 0d |  |  | SI Test Data |  | 5.14 | Green | Richard Puddephatt | Systems Integration Testing (SIT) | GREEN |  | 10.33 |  |  |  |  |
| 940 | 1.4.1.4.2.8.4.2 | Transmit Data Sets to PPs |  | 2d | 2025-03-07 | 2025-03-10 | 939 |  |  | 2025-03-07 | 2025-03-10 | 10d | 34d | 0d |  |  | SI Test Data |  | 5.14 | Green | Richard Puddephatt | Systems Integration Testing (SIT) | GREEN |  | 140.33 |  |  |  |  |
| 941 | 1.4.1.4.2.8.4.3 | PP's Iterative load and data integrity check |  | 20d | 2025-03-11 | 2025-04-07 | 940 |  |  | 2025-03-11 | 2025-04-07 | 5d | 34d | 0d |  |  | PP |  | 5.14 | Green | Richard Puddephatt | Systems Integration Testing (SIT) | GREEN |  | 144.33 |  |  |  |  |
| 942 | 1.4.1.4.2.8.4.4 | Regression - PP's confirmation that test data is ready for SIT Functional | milestone | 0d | 2025-04-07 | 2025-04-07 | 941 |  |  | 2025-04-07 | 2025-04-07 | 0d | 34d | 29d |  |  | SI Test Data |  | 5.14 | Green | Richard Puddephatt | Systems Integration Testing (SIT) | AMBER | SITAG | 171.71 | T3-TE-0082 | MHHS-ART140 MHHS-ART169 | 2/8 - added as a T3 milestone. Awaiting approval at TMAG | T3 |

Notes:
- 917: 02/10/24 - New activities added to this task and existing activities amended. .
- 937: On track to complete Friday 18/10/24.
- 942: Forecasted dates are 04/04/25, which will be baselined once CR55 has been formally approved.

| ID | WBS | Task | Type | Duration | Start | Finish | Predecessors | Complete | Remaining | Baseline start | Baseline finish | Baseline duration | Baseline 1 start | Baseline 1 finish | Total slack | Constraint | Baseline cost | Responsible | Involved | Update Version | MHHS Resource Name | MHHS Programme Phase | Sched Status | RAG | Milestone ID | Text29 | Tier | Artefact ID | Task Status |
| --- | --- | --- | --- | --- | --- | --- | --- | --- | --- | --- | --- | --- | --- | --- | --- | --- | --- | --- | --- | --- | --- | --- | --- | --- | --- | --- | --- | --- | --- |
| 943 | 1.4.1.4.2.9 | **SIT Functional Test Readiness Report** |  | 45d | 2024-01-01 A | 2024-03-01 A |  | 100% |  | 2024-01-01 | 2024-03-01 | 44d | 2024-01-01 | 2024-02-23 |  |  | -0 | N/A | N/A | 5.0 | N/A | Systems Integration Testing (SIT) |  |  |  |  |  |  |  |
| 944 | 1.4.1.4.2.9.1 | **PP SIT Functional Test Readiness Report** |  | 44d | 2024-01-01 A | 2024-02-29 A |  | 100% |  | 2024-01-01 | 2024-02-29 | 44d | 2024-01-01 | 2024-02-09 |  |  | -0 | N/A | N/A | 5.0 | N/A | Systems Integration Testing (SIT) |  |  |  |  |  |  |  |
| 945 | 1.4.1.4.2.9.1.1 | Develop draft Test Readiness Report and submit to Programme for assurance |  | 21d | 2024-01-01 A | 2024-01-29 A |  | 100% |  | 2024-01-01 | 2024-01-29 | 20d | 2024-01-01 | 2024-01-29 |  | start no earlier than 2024-01-01 |  | PP | SI Test | 5.0 |  | Systems Integration Testing (SIT) | Complete | COMPLETE |  |  |  |  |  |
| 946 | 1.4.1.4.2.9.1.2 | Placing Reliance Stage 2 Review |  | 34d | 2024-01-15 A | 2024-02-29 A | 945SS+10d | 100% |  | 2024-01-15 | 2024-02-29 | 34d |  |  |  |  |  | SI Test | PP | 5.12 |  | Systems Integration Testing (SIT) | Complete | COMPLETE |  |  |  |  |  |
| 947 | 1.4.1.4.2.9.1.3 | Finalise Test Readiness Report and submit to Programme for assurance |  | 9d | 2024-01-30 A | 2024-02-09 A | 945 | 100% |  | 2024-01-30 | 2024-02-09 | 10d | 2024-01-29 | 2024-02-09 |  |  |  | PP | SI Test | 5.0 |  | Systems Integration Testing (SIT) | Complete | COMPLETE |  |  |  |  |  |
| 948 | 1.4.1.4.2.9.2 | **SI SIT Functional Test Readiness Report** |  | 40d | 2024-01-01 A | 2024-02-23 A |  | 100% |  | 2024-01-01 | 2024-02-23 | 40d | 2024-01-01 | 2024-02-23 |  |  |  | N/A | N/A | 5.0 | N/A | Systems Integration Testing (SIT) |  |  |  |  |  |  |  |
| 949 | 1.4.1.4.2.9.2.1 | Assure Test Participants' Test Readiness Reports |  | 35d | 2024-01-01 A | 2024-02-16 A | 945SS, 947FF+5d | 100% |  | 2024-01-01 | 2024-02-16 | 35d | 2024-01-01 | 2024-02-16 |  |  |  | SI Test | PP,IPA | 5.0 |  | Systems Integration Testing (SIT) | Complete | COMPLETE |  |  |  |  |  |
| 950 | 1.4.1.4.2.9.2.2 | Develop Overarching SIT Functional Test Readiness Report |  | 20d | 2024-01-22 A | 2024-02-16 A | 949FF | 100% |  | 2024-01-22 | 2024-02-16 | 20d | 2024-01-22 | 2024-02-16 |  |  |  | SI Test |  | 5.0 |  | Systems Integration Testing (SIT) | Complete | COMPLETE |  |  |  |  |  |
| 951 | 1.4.1.4.2.9.2.3 | Artefact review (via TMAG) and updates |  | 5d | 2024-02-19 A | 2024-02-23 A | 950 | 100% |  | 2024-02-19 | 2024-02-23 | 5d | 2024-02-19 | 2024-02-23 |  |  |  | SI Test | PP,IPA | 5.0 |  | Systems Integration Testing (SIT) | Complete | COMPLETE |  |  |  |  |  |
| 952 | 1.4.1.4.2.9.3 | SIT Functional Testing Preparation Complete | milestone | 0d | 2024-03-01 A | 2024-03-01 A | 951FF+5d, 829, 351, 946, 837, 844, 911 | 100% |  | 2024-03-01 | 2024-03-01 | 0d | 2024-03-01 | 2024-03-01 |  |  |  | SI Test | PP,IPA | 5.0 |  | Systems Integration Testing (SIT) | Complete | COMPLETE | T2-TE-0550 | SITAG | T2 |  |  |
| 953 | 1.4.1.4.3 | **SIT Migration Testing Preparation** |  | 505d? | 2022-10-31 A | 2024-10-04 |  | 98% | 8.62d? | 2022-10-31 | 2024-10-04 | 420d | 2022-11-16 | 2024-06-03 | 839d |  | -0 | N/A | N/A | 5.21 | N/A | Systems Integration Testing (SIT) |  |  |  |  |  |  |  |
| 954 | 1.4.1.4.3.1 | **Test Approach & Plan** |  | 75d | 2023-09-07 A | 2023-12-20 A |  | 100% |  | 2023-09-07 | 2023-12-20 | 75d | 2023-09-07 | 2023-12-20 |  |  | -0 | N/A | N/A | 5.0 |  | Systems Integration Testing (SIT) |  |  |  |  |  |  |  |
| 955 | 1.4.1.4.3.1.1 | Develop document with SITWG |  | 32d | 2023-09-07 A | 2023-10-20 A | 2177 | 100% |  | 2023-09-07 | 2023-10-20 | 25d | 2023-09-07 | 2023-10-11 |  | finish no earlier than 2023-10-11 |  | SI Test |  | 5.0 |  | Systems Integration Testing (SIT) | Complete | COMPLETE |  |  |  |  |  |
| 956 | 1.4.1.4.3.1.2 | Draft document review with Code Bodies |  | 8d | 2023-10-23 A | 2023-11-01 A | 955 | 100% |  | 2023-10-23 | 2023-11-01 | 10d | 2023-10-12 | 2023-10-25 |  |  |  | SI Test | Code Bodies | 5.0 |  | Systems Integration Testing (SIT) | Complete | COMPLETE |  |  |  |  |  |
| 957 | 1.4.1.4.3.1.3 | Industry Consultation |  | 10d | 2023-11-02 A | 2023-11-15 A | 956 | 100% |  | 2023-11-02 | 2023-11-15 | 10d |  |  |  |  |  | PP |  | 5.1 |  | Systems Integration Testing (SIT) | Complete | COMPLETE |  |  |  |  |  |
| 958 | 1.4.1.4.3.1.4 | Artefact review (via TMAG) and updates |  | 25d | 2023-11-16 A | 2023-12-20 A | 957 | 100% |  | 2023-11-16 | 2023-12-20 | 30d | 2023-10-26 | 2023-12-20 |  |  |  | SI Test | PP,IPA,Code Bodies | 5.0 |  | Systems Integration Testing (SIT) | Complete | COMPLETE |  |  |  |  |  |
| 959 | 1.4.1.4.3.1.5 | SIT Migration Testing Test Approach & Plan approved | milestone | 0d | 2023-12-20 A | 2023-12-20 A | 958 | 100% |  | 2023-12-20 | 2023-12-20 | 1d | 2023-12-20 | 2023-12-20 |  | finish no earlier than 2023-12-20 |  | SI Test | PP | 5.14 |  | Systems Integration Testing (SIT) | Complete | COMPLETE | T3-TE-0018 | SITAG | T3 | MHHS-ART073 |  |
| 960 | 1.4.1.4.3.2 | **Test Data Approach & Plan** |  | 35d | 2023-11-02 A | 2023-12-20 A |  | 100% |  | 2023-11-02 | 2023-12-20 | 35d | 2023-10-26 | 2023-12-20 |  |  | -0 | N/A | N/A | 5.0 | N/A | Systems Integration Testing (SIT) |  |  |  |  |  |  |  |
| 961 | 1.4.1.4.3.2.1 | Industry Consultation |  | 10d | 2023-11-02 A | 2023-11-15 A | 957SS | 100% |  | 2023-11-02 | 2023-11-15 | 10d |  |  |  |  |  | PP |  | 5.1 | PP | Systems Integration Testing (SIT) | Complete | COMPLETE |  |  |  |  |  |
| 962 | 1.4.1.4.3.2.2 | Artefact review (via TMAG) and updates |  | 25d | 2023-11-16 A | 2023-12-20 A | 961 | 100% |  | 2023-11-16 | 2023-12-20 | 30d | 2023-10-26 | 2023-12-20 |  |  |  | SI Test Data |  | 5.0 | Richard Puddephatt | Systems Integration Testing (SIT) | Complete | COMPLETE |  |  |  |  |  |
| 963 | 1.4.1.4.3.2.3 | SIT Migration Test Data Test Approach & Plan approved | milestone | 0d | 2023-12-20 A | 2023-12-20 A | 962 | 100% |  | 2023-12-20 | 2023-12-20 | 0d | 2023-12-20 | 2023-12-20 |  |  |  | SI Test Data | PP,IPA | 5.14 | Richard Puddephatt | Systems Integration Testing (SIT) | Complete | COMPLETE |  |  |  |  |  |
| 964 | 1.4.1.4.3.3 | **Test scenarios & Test Cases** |  | 207d? | 2023-12-21 A | 2024-10-04 |  | 93% | 14.88d? | 2023-12-21 | 2024-10-04 | 65d | 2023-07-24 | 2024-01-17 | 839d |  | -0 | N/A | N/A | 5.16 | N/A | Systems Integration Testing (SIT) |  |  |  |  |  |  |  |
| 965 | 1.4.1.4.3.3.1 | **Theme 1** |  | 65d | 2023-12-21 A | 2024-03-20 A |  | 100% |  | 2023-12-21 | 2024-03-20 | 65d |  |  |  |  | -0 | N/A | N/A | 5.16 | N/A | Systems Integration Testing (SIT) |  |  |  |  |  |  | -448.67 |
| 966 | 1.4.1.4.3.3.1.1 | Develop Test Scenarios & Test Cases |  | 25d | 2023-12-21 A | 2024-01-24 A | 959 | 100% |  | 2023-12-21 | 2024-01-24 | 25d |  |  |  |  |  | SI Test | SI Test, PP | 5.16 |  |  | Complete | COMPLETE |  |  |  |  |  |
| 967 | 1.4.1.4.3.3.1.2 | Industry Review Workshop |  | 1d | 2024-01-25 A | 2024-01-25 A | 966 | 100% |  | 2024-01-25 | 2024-01-25 | 1d |  |  |  |  |  | SI Test, PP | SI Test, PP | 5.16 |  |  | Complete | COMPLETE |  |  |  |  |  |
| 968 | 1.4.1.4.3.3.1.3 | Industry Consultation Review |  | 6d | 2024-02-05 A | 2024-02-12 A | 967FS+6d | 100% |  | 2024-02-05 | 2024-02-12 | 6d |  |  |  |  |  | SI Test, PP | SI Test, PP | 5.16 |  |  | Complete | COMPLETE |  |  |  |  |  |
| 969 | 1.4.1.4.3.3.1.4 | Review with SIT Working Group |  | 5d | 2024-02-29 A | 2024-03-06 A | 968FS+12d | 100% |  | 2024-02-29 | 2024-03-06 | 5d |  |  |  |  |  | SI Test, PP | SI Test, PP | 5.19 |  |  | Complete | COMPLETE |  |  |  |  |  |
| 970 | 1.4.1.4.3.3.1.5 | SIT Migration Test scenarios & Test Cases Approved - Theme 1 | milestone | 0d | 2024-03-20 A | 2024-03-20 A | 969FS+10d | 100% |  | 2024-03-20 | 2024-03-20 | 0d |  |  |  |  |  | SI Test | SI Test, PP | 5.21 |  | Systems Integration Testing (SIT) | Complete | COMPLETE | T3-TE-0110 | SITAG |  |  |  |

Notes:
- 952: 28/11 - At risk because of challenges with CCP and PP readiness & dependent on successful Secondary Routing Testing. Approved at 1/3 eSITAG
- 959: 24/10 - Amber because consultation window delayed by 5 days. 20/12 - Approved to complete at TMAG on 20/12
- 963: 20/12 - approved at TMAG on 20/12
- 970: 23/1 - New milestones added because of new themed delivery approach. To go to Feb SITAG for approval

| ID | WBS | Task | Type | Duration | Start | Finish | Predecessors | Complete | Remaining | Baseline start | Baseline finish | Baseline duration | Baseline 1 start | Baseline 1 finish | Total slack | Free slack | Constraint | Baseline cost | Responsible | Involved | Task Status | Update Version | MHHS Resource Name | MHHS Programme Phase | Sched Status | RAG | Milestone ID | Text29 |
| --- | --- | --- | --- | --- | --- | --- | --- | --- | --- | --- | --- | --- | --- | --- | --- | --- | --- | --- | --- | --- | --- | --- | --- | --- | --- | --- | --- | --- |
| 971 | 1.4.1.4.3.3.2 | **Theme 2** |  | 85d | 2023-12-21 A | 2024-04-17 A |  | 100% |  | 2023-12-21 | 2024-04-17 | 85d |  |  |  |  |  | -0 | N/A | N/A | -448.67 | 5.16 | N/A | Systems Integration Testing (SIT) |  |  |  |  |
| 972 | 1.4.1.4.3.3.2.1 | Develop Test Scenarios & Test Cases |  | 40d | 2023-12-21 A | 2024-02-14 A | 959 | 100% |  | 2023-12-21 | 2024-02-14 | 40d |  |  |  |  |  |  | SI Test | SI Test, PP |  | 5.16 |  |  | Complete | COMPLETE |  |  |
| 973 | 1.4.1.4.3.3.2.2 | Industry Review Workshop |  | 1d | 2024-02-15 A | 2024-02-15 A | 972 | 100% |  | 2024-02-15 | 2024-02-15 | 1d |  |  |  |  |  |  | SI Test, PP | SI Test, PP |  | 5.16 |  |  | Complete | COMPLETE |  |  |
| 974 | 1.4.1.4.3.3.2.3 | Industry Consultation Review |  | 6d | 2024-02-26 A | 2024-03-04 A | 973FS+6d | 100% |  | 2024-02-26 | 2024-03-04 | 6d |  |  |  |  |  |  | SI Test, PP | SI Test, PP |  | 5.19 |  |  | Complete | COMPLETE |  |  |
| 975 | 1.4.1.4.3.3.2.4 | Review with SIT Working Group |  | 5d | 2024-03-28 A | 2024-04-03 A | 974FS+17d | 100% |  | 2024-03-28 | 2024-04-03 | 5d |  |  |  |  |  |  | SI Test, PP | SI Test, PP |  | 5.16 |  |  | Complete | COMPLETE |  |  |
| 976 | 1.4.1.4.3.3.2.5 | SIT Migration Test scenarios & Test Cases Approved - Theme 2 | milestone | 0d | 2024-04-17 A | 2024-04-17 A | 975FS+10d | 100% |  | 2024-04-17 | 2024-04-17 | 0d |  |  |  |  |  |  | SI Test | SI Test, PP |  | 5.22 |  | Systems Integration Testing (SIT) | Complete | COMPLETE | T3-TE-0111 | SITAG |
| 977 | 1.4.1.4.3.3.3 | **Theme 3** |  | 85d | 2023-12-21 A | 2024-04-17 A |  | 100% |  | 2023-12-21 | 2024-04-17 | 85d |  |  |  |  |  | -0 | N/A | N/A | -448.67 | 5.16 | N/A | Systems Integration Testing (SIT) |  |  |  |  |
| 978 | 1.4.1.4.3.3.3.1 | Develop Test Scenarios & Test Cases |  | 55d | 2023-12-21 A | 2024-03-06 A | 959 | 100% |  | 2023-12-21 | 2024-03-06 | 55d |  |  |  |  |  |  | SI Test | SI Test, PP |  | 5.19 |  |  | Complete | COMPLETE |  |  |
| 979 | 1.4.1.4.3.3.3.2 | Industry Review Workshop |  | 1d | 2024-03-07 A | 2024-03-07 A | 978 | 100% |  | 2024-03-07 | 2024-03-07 | 1d |  |  |  |  |  |  | SI Test, PP | SI Test, PP |  | 5.16 |  |  | Complete | COMPLETE |  |  |
| 980 | 1.4.1.4.3.3.3.3 | Industry Consultation Review |  | 6d | 2024-03-13 A | 2024-03-20 A | 979FS+3d | 100% |  | 2024-03-13 | 2024-03-20 | 6d |  |  |  |  |  |  | SI Test, PP | SI Test, PP |  | 5.16 |  |  | Complete | COMPLETE |  |  |
| 981 | 1.4.1.4.3.3.3.4 | Review with SIT Working Group |  | 5d | 2024-03-28 A | 2024-04-03 A | 980FS+5d | 100% |  | 2024-03-28 | 2024-04-03 | 5d |  |  |  |  |  |  | SI Test, PP | SI Test, PP |  | 5.16 |  |  | Complete | COMPLETE |  |  |
| 982 | 1.4.1.4.3.3.3.5 | SIT Migration Test scenarios & Test Cases Approved - Theme 3 | milestone | 0d | 2024-04-17 A | 2024-04-17 A | 981FS+10d | 100% |  | 2024-04-17 | 2024-04-17 | 0d |  |  |  |  |  |  | SI Test | SI Test, PP |  | 5.22 |  | Systems Integration Testing (SIT) | Complete | COMPLETE | T3-TE-0112 | SITAG |
| 983 | 1.4.1.4.3.3.4 | **RTTM Development** |  | 27d? | 2024-08-29 A | 2024-10-04 |  | 84% | 4.38d? | 2024-08-29 | 2024-10-04 |  |  |  | 839d |  |  |  |  |  | -693.67 | 6.0 |  |  | Overdue Start | GREEN |  |  |
| 984 | 1.4.1.4.3.3.4.1 | Develop Manual SIT Migration RTTM |  | 17d | 2024-08-29 A | 2024-09-20 A |  | 100% |  | 2024-08-29 | 2024-09-20 |  |  |  |  |  | start no earlier than 2024-08-29 |  |  |  |  | 6.0 |  |  | Complete | COMPLETE |  |  |
| 985 | 1.4.1.4.3.3.4.2 | Manual SIT Migration RTTM Complete | milestone | 0d | 2024-09-20 A | 2024-09-20 A | 984 | 100% |  | 2024-09-20 | 2024-09-20 |  |  |  |  |  |  |  |  |  |  | 6.0 |  |  | Complete | COMPLETE |  |  |
| 986 | 1.4.1.4.3.3.4.3 | Develop Automated SIT Migration RTTM |  | 20d | 2024-09-09 A | 2024-10-04 |  | 70% | 6d | 2024-09-09 | 2024-10-04 |  |  |  | 839d | 0d | start no earlier than 2024-09-09 |  |  |  |  | 6.0 |  |  | Green | GREEN |  |  |
| 987 | 1.4.1.4.3.3.4.4 | Automated SIT Migration RTTM Complete | milestone | 0d? | 2024-10-04 | 2024-10-04 | 986 |  |  | 2024-10-04 | 2024-10-04 |  |  |  | 839d |  |  |  |  |  | -13.29 | 6.0 |  |  | Green | GREEN |  |  |
| 988 | 1.4.1.4.3.3.5 | **Gap analysis** |  | 17d? | 2024-09-12 A | 2024-10-04 |  | 60% | 6.8d? | 2024-09-12 | 2024-10-04 |  |  |  | 839d |  |  |  |  |  | -693.67 | 6.0 |  |  | Overdue Start | GREEN |  |  |
| 989 | 1.4.1.4.3.3.5.1 | Identify gaps in test case coverage following RTTM review. |  | 12d | 2024-09-12 A | 2024-09-27 A | 984SS+10d | 100% |  | 2024-09-12 | 2024-09-27 |  |  |  |  |  |  |  |  |  |  | 6.0 |  |  | Complete | COMPLETE |  |  |
| 990 | 1.4.1.4.3.3.5.2 | Address gaps in test case coverage following RTTM review. |  | 12d | 2024-09-19 A | 2024-10-04 | 989SS+5d | 20% | 9.6d | 2024-09-19 | 2024-10-04 |  |  |  | 839d | 0d |  |  |  |  |  | 6.0 |  |  | Green | GREEN |  |  |
| 991 | 1.4.1.4.3.3.5.3 | Gap analysis complete | milestone | 0d? | 2024-10-04 | 2024-10-04 | 990 |  |  | 2024-10-04 | 2024-10-04 |  |  |  | 839d |  |  |  |  |  | -13.29 | 6.0 |  |  | Green | GREEN |  |  |
| 992 | 1.4.1.4.3.4 | **Environments (SIT B)** |  | 435d | 2022-10-31 A | 2024-06-28 A |  | 100% |  | 2022-10-31 | 2024-06-28 | 420d | 2022-11-16 | 2024-05-13 |  |  |  | -0 | N/A | N/A |  | 5.0 | N/A | Systems Integration Testing (SIT) |  |  |  |  |
| 993 | 1.4.1.4.3.4.1 | **PP Environments (SIT B)** |  | 41d | 2024-05-03 A | 2024-06-28 A |  | 100% |  | 2024-05-03 | 2024-06-28 | 26d | 2022-11-16 | 2024-05-13 |  |  |  | -0 | N/A | N/A |  | 5.0 | N/A | Systems Integration Testing (SIT) |  |  |  |  |
| 994 | 1.4.1.4.3.4.1.1 | PP Environments available | milestone | 0d | 2024-05-03 A | 2024-05-03 A | 504 | 100% |  | 2024-05-03 | 2024-05-03 | 0d | 2022-11-16 | 2024-04-01 |  |  | start no earlier than 2024-05-03 |  | PP | SI Test |  | 5.21 | Simon Berry | Systems Integration Testing (SIT) | Complete | COMPLETE |  |  |
| 995 | 1.4.1.4.3.4.1.2 | PP Onboarding / Smoke test |  | 35d | 2024-05-13 A | 2024-06-28 A | 994FS+6d | 100% |  | 2024-05-13 | 2024-06-28 | 20d | 2022-11-16 | 2024-04-01 |  |  |  |  | PP | SI Test |  | 5.21 | Simon Berry | Systems Integration Testing (SIT) | Complete | COMPLETE |  |  |
| 996 | 1.4.1.4.3.4.1.3 | DTN Connectivity Proving Complete |  | 5d | 2024-06-10 A | 2024-06-14 A | 994FS+26d | 100% |  | 2024-06-10 | 2024-06-14 | 0d | 2024-04-15 | 2024-04-26 |  |  |  |  | PP | SI Test |  | 5.21 | Simon Berry | Systems Integration Testing (SIT) | Complete | COMPLETE |  |  |
| 997 | 1.4.1.4.3.4.1.4 | PP Code Deployment | milestone | 0d | 2024-06-14 A | 2024-06-14 A | 996 | 100% |  | 2024-06-14 | 2024-06-14 | 0d | 2024-04-29 | 2024-05-13 |  |  |  |  | PP | SI Test |  | 5.21 | Simon Berry | Systems Integration Testing (SIT) | Complete | COMPLETE |  |  |

Notes:
- 976: 23/1 - New milestones added because of new themed delivery approach
- 982: 23/1 - New milestones added because of new themed delivery approach

| ID | WBS | Task | Type | Duration | Start | Finish | Predecessors | Complete | Remaining | Baseline start | Baseline finish | Baseline duration | Baseline 1 start | Baseline 1 finish | Total slack | Constraint | Baseline cost | Responsible | Involved | Update Version | MHHS Resource Name | MHHS Programme Phase | Sched Status | RAG | Milestone ID | Text29 | Tier | Artefact ID | Guidance |
| --- | --- | --- | --- | --- | --- | --- | --- | --- | --- | --- | --- | --- | --- | --- | --- | --- | --- | --- | --- | --- | --- | --- | --- | --- | --- | --- | --- | --- | --- |
| 998 | 1.4.1.4.3.4.2 | **SI Environments (SIT B)** |  | 425d | 2022-10-31 A | 2024-06-14 A |  | 100% |  | 2022-10-31 | 2024-06-14 | 420d | 2022-11-16 | 2024-05-10 |  |  | -0 | N/A | N/A | 5.0 | N/A | Systems Integration Testing (SIT) |  |  |  |  |  |  |  |
| 999 | 1.4.1.4.3.4.2.1 | Coordinate SIT Participants' SIT B environment preparation |  | 420d | 2022-10-31 A | 2024-06-07 A |  | 100% |  | 2022-10-31 | 2024-06-07 | 420d | 2022-11-16 | 2024-04-01 |  |  |  | SI Test | PP | 5.21 | Simon Berry | Systems Integration Testing (SIT) | Complete | COMPLETE |  |  |  |  |  |
| 1000 | 1.4.1.4.3.4.2.2 | Assure PPs' self-declaration of environment preparation complete (incl. security certificates and security compliance) | milestone | 0d | 2024-06-07 A | 2024-06-07 A | 999 | 100% |  | 2024-06-07 | 2024-06-07 | 0d | 2022-11-16 | 2024-03-29 |  |  |  | SI Test | PP | 5.21 | Simon Berry | Systems Integration Testing (SIT) | Complete | COMPLETE |  |  |  |  |  |
| 1001 | 1.4.1.4.3.4.2.3 | SIT Participants' SIT B environments ready to start connectivity proving (incl. certificates and security compliance) | milestone | 0d | 2024-06-05 A | 2024-06-05 A | 994FS+24d | 100% |  | 2024-06-05 | 2024-06-05 | 0d | 2024-04-01 | 2024-04-01 |  |  |  | SI Test | PP,IPA | 5.26 | Simon Berry | Systems Integration Testing (SIT) | Complete | COMPLETE | T3-TE-0033 | SITAG | T3 |  |  |
| 1002 | 1.4.1.4.3.4.2.4 | Coordinate SIT Participants' SIT B environment connectivity proving |  | 2d | 2024-06-06 A | 2024-06-07 A | 1001 | 100% |  | 2024-06-06 | 2024-06-07 | 19d | 2024-04-01 | 2024-04-26 |  |  |  | SI Test | PP | 5.21 | Simon Berry | Systems Integration Testing (SIT) | Complete | COMPLETE |  |  |  |  |  |
| 1003 | 1.4.1.4.3.4.2.5 | Coordinate deployment of MHHS solution code to SIT Participants' SIT B environments | milestone | 0d | 2024-06-14 A | 2024-06-14 A | 997 | 100% |  | 2024-06-14 | 2024-06-14 | 4d | 2024-04-15 | 2024-04-26 |  |  |  | SI Test | PP | 5.21 | Simon Berry | Systems Integration Testing (SIT) | Complete | COMPLETE |  |  |  |  |  |
| 1004 | 1.4.1.4.3.5 | **SIT Migration Test Readiness Report** |  | 44d | 2024-04-02 A | 2024-05-31 A |  | 100% |  | 2024-04-02 | 2024-05-31 | 44d | 2024-04-02 | 2024-05-27 |  |  | -0 | N/A | N/A | 5.0 | N/A | Systems Integration Testing (SIT) |  |  |  |  |  |  |  |
| 1005 | 1.4.1.4.3.5.1 | **PP SIT Migration Test Readiness Report** |  | 44d | 2024-04-02 A | 2024-05-31 A |  | 100% |  | 2024-04-02 | 2024-05-31 | 44d | 2024-04-02 | 2024-05-13 |  |  | -0 | N/A | N/A | 5.0 | N/A | Systems Integration Testing (SIT) |  |  |  |  |  |  |  |
| 1006 | 1.4.1.4.3.5.1.1 | Develop draft Test Readiness Report and submit to Programme for assurance |  | 20d | 2024-04-02 A | 2024-04-29 A |  | 100% |  | 2024-04-02 | 2024-04-29 | 20d | 2024-04-02 | 2024-04-30 |  | start no earlier than 2024-04-02 |  | PP | SI Test | 5.0 |  | Systems Integration Testing (SIT) | Complete | COMPLETE |  |  |  |  |  |
| 1007 | 1.4.1.4.3.5.1.2 | Placing Reliance Stage 2 Review |  | 35d | 2024-04-15 A | 2024-05-31 A | 1006SS+9d | 100% |  | 2024-04-15 | 2024-05-31 | 35d |  |  |  |  |  | SI Test | PP | 5.12 |  | Systems Integration Testing (SIT) | Complete | COMPLETE |  |  |  |  |  |
| 1008 | 1.4.1.4.3.5.1.3 | Finalise Test Readiness Report and submit to Programme for assurance |  | 10d | 2024-04-30 A | 2024-05-13 A | 1006 | 100% |  | 2024-04-30 | 2024-05-13 | 10d | 2024-04-30 | 2024-05-13 |  |  |  | PP | SI Test | 5.0 |  | Systems Integration Testing (SIT) | Complete | COMPLETE |  |  |  |  |  |
| 1009 | 1.4.1.4.3.5.2 | **SI SIT Migration Test Readiness Report** |  | 40d | 2024-04-02 A | 2024-05-27 A |  | 100% |  | 2024-04-02 | 2024-05-27 | 40d | 2024-04-02 | 2024-05-27 |  |  |  | N/A | N/A | 5.0 | N/A | Systems Integration Testing (SIT) |  |  |  |  |  |  |  |
| 1010 | 1.4.1.4.3.5.2.1 | Assure Test Participants' Test Readiness Reports |  | 35d | 2024-04-02 A | 2024-05-20 A | 1006SS, 1008FF+5d | 100% |  | 2024-04-02 | 2024-05-20 | 35d | 2024-04-02 | 2024-05-20 |  |  |  | SI Test | PP,IPA | 5.0 |  | Systems Integration Testing (SIT) | Complete | COMPLETE |  |  |  |  |  |
| 1011 | 1.4.1.4.3.5.2.2 | Develop Overarching SIT Migration Test Readiness Report |  | 20d | 2024-04-23 A | 2024-05-20 A | 1010FF | 100% |  | 2024-04-23 | 2024-05-20 | 20d | 2024-04-23 | 2024-05-20 |  |  |  | SI Test |  | 5.0 |  | Systems Integration Testing (SIT) | Complete | COMPLETE |  |  |  |  |  |
| 1012 | 1.4.1.4.3.5.2.3 | Artefact review (via SITAG) and updates |  | 5d | 2024-05-21 A | 2024-05-27 A | 1011 | 100% |  | 2024-05-21 | 2024-05-27 | 5d | 2024-05-21 | 2024-05-27 |  |  |  | SI Test | PP,IPA | 5.0 |  | Systems Integration Testing (SIT) | Complete | COMPLETE |  |  |  |  |  |
| 1013 | 1.4.1.4.3.6 | SIT Migration Testing Preparation Complete | milestone | 0d | 2024-06-03 A | 2024-06-03 A | 1012FF+5d, 959, 368, 1007, 970, 976, 982 | 100% |  | 2024-06-03 | 2024-06-03 | 0d | 2024-06-03 | 2024-06-03 |  |  |  | SI Test | PP,IPA | 5.0 |  | Systems Integration Testing (SIT) | Complete | COMPLETE | T2-TE-0650 | SITAG | T2 |  |  |
| 1014 | 1.4.1.4.4 | **SIT Non-Functional Preparation** |  | 337d? | 2023-11-30 A | 2025-03-14 |  | 51% | 165.88d? | 2023-11-30 | 2025-03-14 | 193d | 2023-07-03 | 2024-08-26 | 724d |  | -0 | N/A | N/A | 5.0 | N/A | Systems Integration Testing (SIT) |  |  |  |  |  |  |  |
| 1015 | 1.4.1.4.4.1 | **Test Approach & Plan** |  | 120d | 2023-11-30 A | 2024-05-15 A |  | 100% |  | 2023-11-30 | 2024-05-15 | 120d | 2023-11-30 | 2024-03-20 |  |  | -0 | N/A | N/A | 5.0 | N/A | Systems Integration Testing (SIT) |  |  |  |  |  |  |  |
| 1016 | 1.4.1.4.4.1.1 | Develop document with SITWG |  | 67d | 2023-11-30 A | 2024-03-01 A |  | 100% |  | 2023-11-30 | 2024-03-01 | 67d | 2023-11-30 | 2024-01-10 |  | must start on 2023-11-30 |  | SI Test |  | 5.0 |  | Systems Integration Testing (SIT) | Complete | COMPLETE |  |  |  |  |  |
| 1017 | 1.4.1.4.4.1.2 | Draft document review with Code Bodies |  | 10d | 2024-03-04 A | 2024-03-15 A | 1016 | 100% |  | 2024-03-04 | 2024-03-15 | 10d | 2024-01-11 | 2024-01-24 |  |  |  | SI Test | Code Bodies | 5.0 |  | Systems Integration Testing (SIT) | Complete | COMPLETE |  |  |  |  |  |
| 1018 | 1.4.1.4.4.1.3 | Industry Consultation |  | 10d | 2024-03-18 A | 2024-03-29 A | 1017 | 100% |  | 2024-03-18 | 2024-03-29 | 10d |  |  |  |  |  | PP |  | 5.1 |  | Systems Integration Testing (SIT) | Complete | COMPLETE |  |  |  |  |  |
| 1019 | 1.4.1.4.4.1.4 | Industry Assurance Review |  | 5d | 2024-04-11 A | 2024-04-17 A | 1018FS+8d | 100% |  | 2024-04-11 | 2024-04-17 | 5d |  |  |  |  |  |  |  | 5.16 |  |  | Complete | COMPLETE |  |  |  |  |  |
| 1020 | 1.4.1.4.4.1.5 | SIT Non-Functional Testing Test Approach & Plan approved | milestone | 0d | 2024-05-15 A | 2024-05-15 A | 1019FS+20d | 100% |  | 2024-05-15 | 2024-05-15 | 0d | 2024-03-20 | 2024-03-20 |  |  |  | SI Test | PP | 5.30 | Roger Robar | Systems Integration Testing (SIT) | Complete | COMPLETE | T3-TE-0026 | SITAG | T3 | MHHS-ART073 | 30/7/24: Approved at esitag on 26/7/24 |
| 1021 | 1.4.1.4.4.2 | **Test Data Approach & Plan** |  | 41d | 2024-03-20 A | 2024-05-15 A |  | 100% |  | 2024-03-20 | 2024-05-15 | 41d | 2024-01-25 | 2024-03-20 |  |  | -0 | N/A | N/A | 5.0 | N/A | Systems Integration Testing (SIT) |  |  |  |  |  |  |  |
| 1022 | 1.4.1.4.4.2.1 | Industry Consultation |  | 14d | 2024-03-20 A | 2024-04-08 A | 1018SS+2d | 100% |  | 2024-03-20 | 2024-04-08 | 14d |  |  |  |  |  | PP |  | 5.1 | Richard Puddephatt | Systems Integration Testing (SIT) | Complete | COMPLETE |  |  |  |  |  |
| 1023 | 1.4.1.4.4.2.2 | Artefact review (via SITAG) and updates |  | 27d | 2024-04-09 A | 2024-05-15 A | 1022 | 100% |  | 2024-04-09 | 2024-05-15 | 27d | 2024-01-25 | 2024-03-13 |  |  |  | SI Test |  | 5.0 | Richard Puddephatt | Systems Integration Testing (SIT) | Complete | COMPLETE |  |  |  |  |  |
| 1024 | 1.4.1.4.4.2.3 | SIT Non-Functional Testing Test Data Approach & Plan approved | milestone | 0d | 2024-05-15 A | 2024-05-15 A | 1020FF, 1023 | 100% |  | 2024-05-15 | 2024-05-15 | 0d | 2024-03-20 | 2024-03-20 |  |  |  | SI Test | PP,IPA | 5.24 | Richard Puddephatt | Systems Integration Testing (SIT) | Complete | COMPLETE | T3-TE-0113 | SITAG |  |  |  |

Notes:
- 1001: 3/6: SI coordinated smoke test will run from 5th - 7th June
- 1013: 28/5: Amber because subject to SITAG agreement on work-off items. 4/6 eSITAG approved milestone completion subject to work-off items
- 1020: Deferred from May SITAG approval, pending further confirmation and agreement of DIP-Helix Phase 1 testing.~ Start of SIT Non-Functional Testing at risk. Phase / Notes (2): 1 approach to be concluded and re-issued for SITAG approval. Forecast SITAG TBC
- 1024: 13/2 - To go to Feb SITAG as a new milestone. 21/2/24 - Approved at SITAG on 21/2/24 as a new milestone. 3/4 At risk because of tight delivery schedule (added as amber to align with Lee's status)

| ID | WBS | Task | Type | Duration | Start | Finish | Predecessors | Complete | Remaining | Actual finish | Baseline start | Baseline finish | Baseline duration | Baseline 1 start | Baseline 1 finish | Total slack | Free slack | Constraint | Baseline cost | Responsible | Involved | Update Version | MHHS Resource Name | MHHS Programme Phase | Task Status | Sched Status | RAG | Guidance | Milestone ID | Text29 |
| --- | --- | --- | --- | --- | --- | --- | --- | --- | --- | --- | --- | --- | --- | --- | --- | --- | --- | --- | --- | --- | --- | --- | --- | --- | --- | --- | --- | --- | --- | --- |
| 1025 | 1.4.1.4.4.3 | **Test scenarios & Test Cases** |  | 98d? | 2024-03-04 A | 2024-07-17 |  | 78% | 21.45d? |  | 2024-03-04 | 2024-07-17 | 123d | 2023-07-24 | 2024-01-17 |  |  |  | -0 | N/A | N/A | 5.21 | N/A | Systems Integration Testing (SIT) |  |  |  |  |  |  |
| 1026 | 1.4.1.4.4.3.1 | **Theme 1** |  | 78d | 2024-03-04 A | 2024-06-19 A |  | 100% |  |  | 2024-03-04 | 2024-06-19 | 78d |  |  |  |  |  | -0 | N/A | N/A | 5.21 | N/A | Systems Integration Testing (SIT) | -448.67 |  |  |  |  |  |
| 1027 | 1.4.1.4.4.3.1.1 | Develop Test Scenarios & Test Cases |  | 33d | 2024-03-04 A | 2024-04-17 A | 1016 | 100% |  |  | 2024-03-04 | 2024-04-17 | 33d |  |  |  |  |  |  | SI Test | SI Test, PP | 5.21 |  |  |  | Complete | COMPLETE |  |  |  |
| 1028 | 1.4.1.4.4.3.1.2 | Industry Review Workshop |  | 1d | 2024-04-18 A | 2024-04-18 A | 1027 | 100% |  |  | 2024-04-18 | 2024-04-18 | 1d |  |  |  |  |  |  | SI Test, PP | SI Test, PP | 5.21 |  |  |  | Complete | COMPLETE |  |  |  |
| 1029 | 1.4.1.4.4.3.1.3 | Industry Consultation Review |  | 7d | 2024-05-02 A | 2024-05-10 A | 1028FS+9d | 100% |  |  | 2024-05-02 | 2024-05-10 | 7d |  |  |  |  |  |  | SI Test, PP | SI Test, PP | 5.21 |  |  |  | Complete | COMPLETE |  |  |  |
| 1030 | 1.4.1.4.4.3.1.4 | Review with NFT Working Group |  | 5d | 2024-05-31 A | 2024-06-06 A | 1029FS+14d | 100% |  |  | 2024-05-31 | 2024-06-06 | 5d |  |  |  |  |  |  | SI Test, PP | SI Test, PP | 5.21 |  |  |  | Complete | COMPLETE |  |  |  |
| 1031 | 1.4.1.4.4.3.1.5 | SIT NFT Scenarios & Test Cases Approved - Theme 1 | milestone | 0d | 2024-06-19 A | 2024-06-19 A | 1030FS+9d | 100% |  |  | 2024-06-19 | 2024-06-19 | 0d |  |  |  |  |  |  | SI Test | SI Test, PP | 5.30 | Roger Robar | Systems Integration Testing (SIT) |  | Complete | COMPLETE | 30/7/24: Approved at esitag on 26/7/24 | T3-TE-0114 | SITAG |
| 1032 | 1.4.1.4.4.3.2 | **Theme 2** |  | 98d | 2024-03-04 A | 2024-07-17 A |  | 100% |  |  | 2024-03-04 | 2024-07-17 | 98d |  |  |  |  |  |  | N/A | N/A | 5.21 | N/A | Systems Integration Testing (SIT) | -448.67 |  |  |  |  |  |
| 1033 | 1.4.1.4.4.3.2.1 | Develop Test Scenarios & Test Cases |  | 53d | 2024-03-04 A | 2024-05-15 A | 1016 | 100% |  |  | 2024-03-04 | 2024-05-15 | 53d |  |  |  |  |  |  | SI Test | SI Test, PP | 5.21 |  |  |  | Complete | COMPLETE |  |  |  |
| 1034 | 1.4.1.4.4.3.2.2 | Industry Review Workshop |  | 1d | 2024-05-16 A | 2024-05-16 A | 1033 | 100% |  |  | 2024-05-16 | 2024-05-16 | 1d |  |  |  |  |  |  | SI Test, PP | SI Test, PP | 5.21 |  |  |  | Complete | COMPLETE |  |  |  |
| 1035 | 1.4.1.4.4.3.2.3 | Industry Consultation Review |  | 7d | 2024-05-20 A | 2024-05-28 A | 1034FS+1d | 100% |  |  | 2024-05-20 | 2024-05-28 | 7d |  |  |  |  |  |  | SI Test, PP | SI Test, PP | 5.21 |  |  |  | Complete | COMPLETE |  |  |  |
| 1036 | 1.4.1.4.4.3.2.4 | Review with NFT Working Group |  | 5d | 2024-06-28 A | 2024-07-04 A | 1035FS+22d | 100% |  |  | 2024-06-28 | 2024-07-04 | 5d |  |  |  |  |  |  | SI Test, PP | SI Test, PP | 5.21 |  |  |  | Complete | COMPLETE |  |  |  |
| 1037 | 1.4.1.4.4.3.2.5 | SIT NFT Scenarios & Test Cases Approved - Theme 2 | milestone | 0d | 2024-07-17 A | 2024-07-17 A | 1036FS+9d | 100% |  |  | 2024-07-17 | 2024-07-17 | 0d |  |  |  |  |  |  | SI Test | SI Test, PP | 5.22 |  | Systems Integration Testing (SIT) |  | Complete | COMPLETE |  | T3-TE-0115 | SITAG |
| 1038 | 1.4.1.4.4.3.3 | **Theme 3** |  | 98d? | 2024-03-04 A | 2024-07-17 |  | 100% |  | 2024-09-18 | 2024-03-04 | 2024-07-17 | 123d |  |  |  |  |  | -0 | N/A | N/A | 6.0 | N/A | Systems Integration Testing (SIT) | -448.67 |  |  |  |  |  |
| 1039 | 1.4.1.4.4.3.3.1 | Develop Test Scenarios & Test Cases |  | 63d | 2024-03-04 A | 2024-05-29 A | 1016 | 100% |  |  | 2024-03-04 | 2024-05-29 | 63d |  |  |  |  |  |  | SI Test | SI Test, PP | 6.0 |  |  |  | Complete | COMPLETE |  |  |  |
| 1040 | 1.4.1.4.4.3.3.2 | Industry Review Workshop |  | 1d | 2024-05-30 A | 2024-05-30 A | 1039 | 100% |  |  | 2024-05-30 | 2024-05-30 | 1d |  |  |  |  |  |  | SI Test, PP | SI Test, PP | 6.0 |  |  |  | Complete | COMPLETE |  |  |  |
| 1041 | 1.4.1.4.4.3.3.3 | Industry Consultation Review |  | 6d | 2024-06-10 A | 2024-06-17 A | 1040FS+6d | 100% |  |  | 2024-06-10 | 2024-06-17 | 6d |  |  |  |  |  |  | SI Test, PP | SI Test, PP | 6.0 |  |  |  | Complete | COMPLETE |  |  |  |
| 1042 | 1.4.1.4.4.3.3.4 | Review with NFT Working Group |  | 5d | 2024-06-28 A | 2024-07-04 A | 1041FS+8d | 100% |  |  | 2024-06-28 | 2024-07-04 | 30d |  |  |  |  |  |  | SI Test, PP | SI Test, PP | 6.0 | Roger Robar |  |  | Complete | COMPLETE |  |  |  |
| 1043 | 1.4.1.4.4.3.3.5 | SIT NFT Scenarios & Test Cases Approved - Theme 3 | milestone | 0d | 2024-09-18 A | 2024-09-18 A | 1042FS+9d | 100% |  |  | 2024-09-18 | 2024-09-18 | 0d |  |  |  |  | start no earlier than 2024-09-18 |  | SI Test | SI Test, PP | 5.30 | Roger Robar | Systems Integration Testing (SIT) |  | Complete | COMPLETE | 31/7/24: baseline date change approved at esitag on 26/7/24 | T3-TE-0116 | SITAG |
| 1044 | 1.4.1.4.4.3.4 | **SIT NFT Programme RTTM** |  | 21d? | 2024-09-18 | 2024-10-16 |  |  |  |  | 2024-09-18 | 2024-10-16 |  |  |  | 831d |  |  |  |  |  | 6.0 |  |  | -197.67 | Overdue Start | RED |  |  |  |
| 1045 | 1.4.1.4.4.3.4.1 | Develop Manual SIT NFT RTTM |  | 15d | 2024-09-18 | 2024-10-08 | 1043 |  |  |  | 2024-09-18 | 2024-10-08 |  |  |  | 831d | 0d |  |  |  |  | 6.0 |  |  | -29.67 | Green | GREEN |  |  |  |
| 1046 | 1.4.1.4.4.3.4.2 | Review with SRO |  | 1d? | 2024-10-09 | 2024-10-09 | 1045 |  |  |  | 2024-10-09 | 2024-10-09 |  |  |  | 836d |  |  |  |  |  | 6.0 |  |  | -8.67 | Green | GREEN |  |  |  |
| 1047 | 1.4.1.4.4.3.4.3 | Manual SIT NFT RTTM Complete | milestone | 0d | 2024-10-08 | 2024-10-08 | 1045 |  |  |  | 2024-10-08 | 2024-10-08 |  |  |  | 831d | 0d |  |  |  |  | 6.0 |  |  | -9.29 | Green | GREEN |  |  |  |
| 1048 | 1.4.1.4.4.3.4.4 | Develop Automated SIT NFT RTTM |  | 5d | 2024-10-09 | 2024-10-15 | 1047 |  |  |  | 2024-10-09 | 2024-10-15 |  |  |  | 831d | 0d |  |  |  |  | 6.0 |  |  | -8.67 | Green | GREEN |  |  |  |
| 1049 | 1.4.1.4.4.3.4.5 | Review with SRO |  | 1d? | 2024-10-16 | 2024-10-16 | 1048 |  |  |  | 2024-10-16 | 2024-10-16 |  |  |  | 831d |  |  |  |  |  | 6.0 |  |  | -1.67 | Green | GREEN |  |  |  |
| 1050 | 1.4.1.4.4.3.4.6 | Automated SIT NFT RTTM Complete | milestone | 0d | 2024-10-15 | 2024-10-15 | 1048 |  |  |  | 2024-10-15 | 2024-10-15 |  |  |  | 832d |  |  |  |  |  | 6.0 |  |  | -2.29 | Green | GREEN |  |  |  |

Notes:
- 1025: 12/09/24 - Forecast date changed to reflect the SI Plan
- 1031: Deferred from June SITAG approval, pending further confirmation and agreement of DIP-Helix Phase 1 testing. Start of SIT Non-Functional Testing at risk. Phase 1 approach to be concluded and re-issued for SITAG approval. Forecast SITAG TBC
- 1037: Date missed because of the deferment of the SIT Non-Functional Test Approach and Plan. This increases the risk to the start of SIT Non-Functional Testing
- 1038: 12/09/24 - Forecast date changed in line with SI Plan
- 1042: 12/09/24 - Duration shortened to 5 days to be in line with the SI Plan.
- 1043: Date missed because of uncertainty around test scenarios based PPs engagement. Test cases may not be ready in time for the start of SIT Non-Functional testing. Approval forecast at Sep SITAG in prep for testing commencing 7/10.

| ID | WBS | Task | Type | Duration | Start | Finish | Predecessors | Complete | Remaining | Baseline start | Baseline finish | Baseline duration | Baseline 1 start | Baseline 1 finish | Total slack | Free slack | Constraint | Baseline cost | Task Status | Update Version | Sched Status | RAG | Responsible | Involved | MHHS Resource Name | MHHS Programme Phase | Action |
| --- | --- | --- | --- | --- | --- | --- | --- | --- | --- | --- | --- | --- | --- | --- | --- | --- | --- | --- | --- | --- | --- | --- | --- | --- | --- | --- | --- |
| 1051 | 1.4.1.4.4.3.5 | **NFT Performance Tool Theme 1 Setup** |  | 225d? | 2024-03-04 A | 2025-01-10 |  | 68% | 73d? | 2024-03-04 | 2025-01-10 |  |  |  | 769d |  |  |  | -205.67 | 6.1 | Overdue Start | RED |  |  |  |  |  |
| 1052 | 1.4.1.4.4.3.5.1 | Theme 1 injection tool initial POC |  | 85d? | 2024-03-04 A | 2024-06-28 A |  | 100% |  | 2024-03-04 | 2024-06-28 |  |  |  |  |  |  |  |  | 6.1 | Complete | COMPLETE |  |  |  |  |  |
| 1053 | 1.4.1.4.4.3.5.2 | Theme 1 injection tool configuration and validation against DIP SIM (IR7.1) |  | 38d | 2024-07-01 A | 2024-08-21 A | 1052 | 100% |  | 2024-07-01 | 2024-08-21 |  |  |  |  |  |  |  |  | 6.1 | Complete | COMPLETE |  |  |  |  |  |
| 1054 | 1.4.1.4.4.3.5.3 | Theme 1 injection tool configuration and validation against DIP SIM (IR8.1) |  | 29d | 2024-08-22 A | 2024-10-01 A | 1053 | 100% |  | 2024-08-22 | 2024-10-01 |  |  |  |  |  |  |  |  | 6.1 | Complete | COMPLETE |  |  |  |  |  |
| 1055 | 1.4.1.4.4.3.5.4 | Theme 1 injection tool configuration and validation againast UIT DIP (IR8.1) |  | 11d | 2024-10-02 | 2024-10-16 | 1054 |  |  | 2024-10-02 | 2024-10-16 |  |  |  | 769d | 0d |  |  | -15.67 | 6.1 | Green | GREEN |  |  |  |  |  |
| 1056 | 1.4.1.4.4.3.5.5 | Theme 1 injection tool configuration and validation against SIT-B DIP (IR8.3) |  | 62d? | 2024-10-17 | 2025-01-10 | 1055 |  |  | 2024-10-17 | 2025-01-10 |  |  |  | 769d |  |  |  | -0.67 | 6.1 | Green | GREEN |  |  |  |  |  |
| 1057 | 1.4.1.4.4.4 | **Environments (SIT B)** |  | 94d? | 2024-08-27 A | 2025-01-03 |  |  | 94d? | 2024-08-27 | 2025-01-03 | 0d | 2024-07-30 | 2024-08-05 | 774d |  |  | -0 |  | 5.0 |  |  | N/A | N/A | N/A | Systems Integration Testing (SIT) |  |
| 1058 | 1.4.1.4.4.4.1 | **PP Environments (SIT B)** |  | 0d | 2024-08-27 A | 2024-08-27 A |  | 100% |  | 2024-08-27 | 2024-08-27 | 0d | 2024-07-30 | 2024-08-05 |  |  |  | -0 |  | 5.0 |  |  | N/A | N/A | N/A | Systems Integration Testing (SIT) |  |
| 1059 | 1.4.1.4.4.4.1.1 | Deployment of MHHS solution code to SIT B environments | milestone | 0d | 2024-08-27 A | 2024-08-27 A |  | 100% |  | 2024-08-27 | 2024-08-27 | 0d | 2024-07-30 | 2024-08-05 |  |  | start no earlier than 2024-08-27 |  |  | 5.21 | Complete | COMPLETE | PP | SI Test | Heath Thomas | Systems Integration Testing (SIT) | 26/3/24: Lee said change to SB and align to IR7 |
| 1060 | 1.4.1.4.4.4.2 | **SI Environments (SIT B)** |  | 0d | 2024-08-27 | 2024-08-27 |  |  |  | 2024-08-27 | 2024-08-27 | 0d | 2024-07-30 | 2024-08-05 | 868d |  |  | -0 |  | 5.0 |  |  | N/A | N/A | N/A | Systems Integration Testing (SIT) |  |
| 1061 | 1.4.1.4.4.4.2.1 | Coordinate deployment of MHHS solution code to SIT Participants' SIT B environments | milestone | 0d | 2024-08-27 | 2024-08-27 | 1059SS |  |  | 2024-08-27 | 2024-08-27 | 0d | 2024-07-30 | 2024-08-05 | 868d |  |  |  | -51.67 | 5.21 | Green | GREEN | SI Test | PP | Heath Thomas | Systems Integration Testing (SIT) |  |
| 1062 | 1.4.1.4.4.4.3 | **Helix and Avanade Environments Upscale** |  | 10d? | 2024-12-23 | 2025-01-03 |  |  |  | 2024-12-23 | 2025-01-03 |  |  |  | 60d |  |  |  | -686.67 | 6.0 | Overdue Start | RED |  |  |  |  |  |
| 1063 | 1.4.1.4.4.4.3.1 | Environment Uplift Window |  | 10d? | 2024-12-23 | 2025-01-03 | 1271 |  |  | 2024-12-23 | 2025-01-03 |  |  |  | 60d | 0d |  |  | 66.33 | 6.0 | Green | GREEN |  |  |  |  |  |
| 1064 | 1.4.1.4.4.5 | **Test Data - Non-Functional and Operational (SIT B)** |  | 50d? | 2025-01-06 | 2025-03-14 |  |  |  | 2025-01-06 | 2025-03-14 |  |  |  | 60d |  |  |  | -686.67 | 6.0 | Overdue Start | RED |  |  |  |  |  |
| 1065 | 1.4.1.4.4.5.1 | **Data Load** |  | 50d? | 2025-01-06 | 2025-03-14 |  |  |  | 2025-01-06 | 2025-03-14 |  |  |  | 60d |  |  |  | -689.67 | 6.0 | Overdue Start | RED |  |  |  |  |  |
| 1066 | 1.4.1.4.4.5.1.1 | Non-Functional Theme 1 (Helix & DIP Volume Testing) Data Load |  | 5d? | 2025-01-06 | 2025-01-10 | 1063 |  |  | 2025-01-06 | 2025-01-10 |  |  |  | 60d | 0d |  |  | 80.33 | 6.0 | Green | GREEN |  |  |  |  |  |
| 1067 | 1.4.1.4.4.5.1.2 | Non-Functional Theme 2 & 3 (Helix and DIP) Data Load |  | 5d | 2025-02-03 | 2025-02-07 | 1327 |  |  | 2025-02-03 | 2025-02-07 |  |  |  | 70d | 0d |  |  | 108.33 | 6.0 | Green | GREEN |  |  |  |  |  |
| 1068 | 1.4.1.4.4.5.1.3 | Non-Functional Themes 2 & 3 (Central Parties and PPs) Data Load |  | 20d? | 2025-01-06 | 2025-01-31 | 1063 |  |  | 2025-01-06 | 2025-01-31 |  |  |  | 100d | 30d |  |  | 80.33 | 6.0 | Green | GREEN |  |  |  |  |  |
| 1069 | 1.4.1.4.4.5.1.4 | Operational Themes 1, 2 & 3 (Batch 2) (Central Parties and PPs) Data Load |  | 20d? | 2025-01-06 | 2025-01-31 | 1063 |  |  | 2025-01-06 | 2025-01-31 |  |  |  | 65d | 5d | start no earlier than 2025-01-06 |  | 80.33 | 6.0 | Green | GREEN |  |  |  |  |  |
| 1070 | 1.4.1.4.4.5.1.5 | Operational Themes 1, 2 & 3 (Batch 2) (Helix & DIP) Data Load |  | 5d | 2025-02-03 | 2025-02-07 | 1327 |  |  | 2025-02-03 | 2025-02-07 |  |  |  | 60d | 0d |  |  | 108.33 | 6.0 | Green | GREEN |  |  |  |  |  |
| 1071 | 1.4.1.4.4.5.1.6 | Non-Functional and Operational Test Data Preparation Complete | milestone | 0d | 2025-02-07 | 2025-02-07 | 1070 |  |  | 2025-02-07 | 2025-02-07 |  |  |  | 749d |  |  |  | 112.71 | 6.0 | Green | GREEN |  |  |  |  |  |
| 1072 | 1.4.1.4.4.5.1.7 | Non-Functional Theme 2 & 3 PP Preparation |  | 25d? | 2025-02-10 | 2025-03-14 | 1067 |  |  | 2025-02-10 | 2025-03-14 |  |  |  | 70d | 0d |  |  | 115.33 | 6.0 | Green | GREEN |  |  |  |  |  |
| 1073 | 1.4.1.4.4.6 | **SIT Non-Functional Test Readiness Report** |  | 184d | 2024-06-25 A | 2025-03-07 |  | 19% | 148.71d | 2024-06-25 | 2025-03-07 | 44d | 2024-06-25 | 2024-08-19 | 70d |  |  | -0 |  | 5.0 |  |  | N/A | N/A | N/A | Systems Integration Testing (SIT) |  |
| 1074 | 1.4.1.4.4.6.1 | **PP SIT Non-Functional Test Readiness Report** |  | 184d | 2024-06-25 A | 2025-03-07 |  | 18% | 150.71d | 2024-06-25 | 2025-03-07 | 44d | 2024-06-25 | 2024-08-05 | 70d |  |  | -0 |  | 5.0 |  |  | N/A | N/A | N/A | Systems Integration Testing (SIT) |  |
| 1075 | 1.4.1.4.4.6.1.1 | Develop draft Test Readiness Report and submit to Programme for assurance |  | 20d | 2024-06-25 A | 2024-07-22 A |  | 100% |  | 2024-06-25 | 2024-07-22 | 20d | 2024-06-25 | 2024-07-22 |  |  | start no earlier than 2024-06-25 |  |  | 5.0 | Complete | COMPLETE | PP | SI Test | Roger Robar | Systems Integration Testing (SIT) |  |
| 1076 | 1.4.1.4.4.6.1.2 | Placing Reliance Stage 2 Review |  | 180d | 2024-07-01 A | 2025-03-07 |  | 16% | 152d | 2024-07-01 | 2025-03-07 | 40d |  |  | 70d | 0d |  |  |  | 5.12 | Green | GREEN | SI Test | PP | Roger Robar | Systems Integration Testing (SIT) |  |
| 1077 | 1.4.1.4.4.6.1.3 | Finalise Test Readiness Report and submit to Programme for assurance |  | 104d | 2024-07-23 A | 2024-12-13 | 1075 | 7% | 97d | 2024-07-23 | 2024-12-13 | 10d | 2024-07-23 | 2024-08-05 | 7d | 0d |  |  |  | 5.0 | Green | GREEN | PP | SI Test | Roger Robar | Systems Integration Testing (SIT) |  |

Notes:
- 1059: 25/3: SB - Date aligns to IR8 code delivery for SIT B
- 1061: 25/3: SB - Date aligns to IR8 code delivery for SIT B
- 1076: 04/10/24 - Duration has been reduced so it finis
- 1077: 10/10/24 - Duration extended to 94 days.

| ID | WBS | Task | Type | Duration | Start | Finish | Predecessors | Complete | Remaining | Baseline start | Baseline finish | Baseline duration | Baseline 1 start | Baseline 1 finish | Total slack | Free slack | Constraint | Baseline cost | Responsible | Involved | Update Version | MHHS Resource Name | MHHS Programme Phase | Sched Status | RAG | Task Status | Milestone ID | Text29 | Tier | Artefact ID | Guidance |
| --- | --- | --- | --- | --- | --- | --- | --- | --- | --- | --- | --- | --- | --- | --- | --- | --- | --- | --- | --- | --- | --- | --- | --- | --- | --- | --- | --- | --- | --- | --- | --- |
| 1078 | 1.4.1.4.4.6.2 | **SI SIT Non-Functional Test Readiness Report** |  | 144d | 2024-06-25 A | 2025-01-10 |  | 22% | 112.84d | 2024-06-25 | 2025-01-10 | 40d | 2024-06-25 | 2024-08-19 | 95d |  |  |  | N/A | N/A | 5.0 | N/A | Systems Integration Testing (SIT) |  |  |  |  |  |  |  |  |
| 1079 | 1.4.1.4.4.6.2.1 | Assure Test Participants' Test Readiness Reports |  | 114d | 2024-06-25 A | 2024-12-13 | 1075SS, 1077FF | 19% | 92d | 2024-06-25 | 2024-12-13 | 35d | 2024-06-25 | 2024-08-12 | 7d | 0d |  |  | SI Test | PP,IPA | 5.0 | Roger Robar | Systems Integration Testing (SIT) | Green | GREEN |  |  |  |  |  |  |
| 1080 | 1.4.1.4.4.6.2.2 | Develop Overarching SIT Non-Functional Test Readiness Report |  | 15d | 2024-12-02 A | 2024-12-20 | 1079FS-10d | 47% | 8d | 2024-12-02 | 2024-12-20 | 20d | 2024-07-16 | 2024-08-12 | 95d | 0d |  |  | SI Test |  | 5.0 | Roger Robar | Systems Integration Testing (SIT) | Green | GREEN |  |  |  |  |  |  |
| 1081 | 1.4.1.4.4.6.2.3 | Artefact review (via SITAG / SRO) and updates |  | 5d | 2025-01-06 | 2025-01-10 | 1080FS+10d |  |  | 2025-01-06 | 2025-01-10 | 5d | 2024-08-13 | 2024-08-19 | 95d | 25d |  |  | SI Test | PP,IPA | 5.0 | Roger Robar | Systems Integration Testing (SIT) | Green | GREEN | 80.33 |  |  |  |  |  |
| 1082 | 1.4.1.4.4.7 | SIT Non-Functional Testing Preparation Complete | milestone | 0d | 2025-03-07 | 2025-03-07 | 1081FF+15d, 829, 385, 1031, 1037, 1043, 1076 |  |  | 2025-03-07 | 2025-03-07 | 0d | 2024-08-26 | 2024-08-26 | 70d | 0d |  |  | SI Test | PP,IPA | 5.0 | Roger Robar | Systems Integration Testing (SIT) | Green | AMBER | 140.71 | T2-TE-0700 | SITAG | T2 |  |  |
| 1083 | 1.4.1.4.5 | **SIT Operational Preparation** |  | 262d? | 2024-02-01 A | 2025-01-31 |  | 38% | 163.23d? | 2024-02-01 | 2025-01-31 | 283d | 2023-08-03 | 2025-03-10 | 754d |  |  | -0 | N/A | N/A | 5.0 | N/A | Systems Integration Testing (SIT) |  |  |  |  |  |  |  |  |
| 1084 | 1.4.1.4.5.1 | **Test Approach & Plan** |  | 75d | 2024-02-01 A | 2024-05-15 A |  | 100% |  | 2024-02-01 | 2024-05-15 | 75d | 2024-02-01 | 2024-05-15 |  |  |  | -0 | N/A | N/A | 5.0 | N/A | Systems Integration Testing (SIT) |  |  |  |  |  |  |  |  |
| 1085 | 1.4.1.4.5.1.1 | Develop document with SITWG |  | 25d | 2024-02-01 A | 2024-03-06 A |  | 100% |  | 2024-02-01 | 2024-03-06 | 25d | 2024-02-01 | 2024-03-06 |  |  | must start on 2024-02-01 |  | SI Test |  | 5.0 |  | Systems Integration Testing (SIT) | Complete | COMPLETE |  |  |  |  |  |  |
| 1086 | 1.4.1.4.5.1.2 | Draft document review with Code Bodies |  | 4d | 2024-03-21 A | 2024-03-26 A | 1085FS+10d | 100% |  | 2024-03-21 | 2024-03-26 | 10d | 2024-03-07 | 2024-03-20 |  |  |  |  | SI Test | Code Bodies | 5.0 |  | Systems Integration Testing (SIT) | Complete | COMPLETE |  |  |  |  |  |  |
| 1087 | 1.4.1.4.5.1.3 | Industry Consultation |  | 10d | 2024-03-27 A | 2024-04-09 A | 1086 | 100% |  | 2024-03-27 | 2024-04-09 | 10d |  |  |  |  |  |  | PP |  | 5.1 |  | Systems Integration Testing (SIT) | Complete | COMPLETE |  |  |  |  |  |  |
| 1088 | 1.4.1.4.5.1.4 | Artefact review (via SITAG) and updates |  | 26d | 2024-04-10 A | 2024-05-15 A | 1087 | 100% |  | 2024-04-10 | 2024-05-15 | 30d | 2024-03-21 | 2024-05-15 |  |  |  |  | SI Test | PP,IPA,Code Bodies | 5.0 |  | Systems Integration Testing (SIT) | Complete | COMPLETE |  |  |  |  |  |  |
| 1089 | 1.4.1.4.5.1.5 | SIT Operational Testing Test Approach & Plan approved | milestone | 0d | 2024-05-15 A | 2024-05-15 A | 1088 | 100% |  | 2024-05-15 | 2024-05-15 | 0d | 2024-05-15 | 2024-05-15 |  |  |  |  | SI Test | PP | 5.24 |  | Systems Integration Testing (SIT) | Complete | COMPLETE |  | T3-TE-0029 | SITAG | T3 | MHHS-ART073 |  |
| 1090 | 1.4.1.4.5.2 | **Test Data Approach & Plan** |  | 36d | 2024-03-27 A | 2024-05-15 A |  | 100% |  | 2024-03-27 | 2024-05-15 | 36d | 2024-03-21 | 2024-05-15 |  |  |  | -0 | N/A | N/A | 5.0 | N/A | Systems Integration Testing (SIT) |  |  |  |  |  |  |  |  |
| 1091 | 1.4.1.4.5.2.1 | Industry Consultation |  | 10d | 2024-03-27 A | 2024-04-09 A | 1087SS | 100% |  | 2024-03-27 | 2024-04-09 | 10d |  |  |  |  |  |  | PP |  | 5.1 | Richard Puddephatt | Systems Integration Testing (SIT) | Complete | COMPLETE |  |  |  |  |  |  |
| 1092 | 1.4.1.4.5.2.2 | Artefact review (via SITAG) and updates |  | 26d | 2024-04-10 A | 2024-05-15 A | 1091 | 100% |  | 2024-04-10 | 2024-05-15 | 26d | 2024-03-21 | 2024-05-15 |  |  |  |  | SI Test |  | 5.0 | Richard Puddephatt | Systems Integration Testing (SIT) | Complete | COMPLETE |  |  |  |  |  |  |
| 1093 | 1.4.1.4.5.2.3 | SIT Operational Testing Test Data Approach & Plan approved | milestone | 0d | 2024-05-15 A | 2024-05-15 A | 1092 | 100% |  | 2024-05-15 | 2024-05-15 | 0d | 2024-05-15 | 2024-05-15 |  |  |  |  | SI Test | PP,IPA | 5.0 | Richard Puddephatt | Systems Integration Testing (SIT) | Complete | COMPLETE |  |  |  |  |  |  |
| 1094 | 1.4.1.4.5.3 | **Test scenarios & Test Cases** |  | 213d? | 2024-04-10 A | 2025-01-31 |  | 31% | 146.55d? | 2024-04-10 | 2025-01-31 | 116d | 2023-07-24 | 2024-01-17 | 754d |  |  | -0 | N/A | N/A | 5.21 | N/A | Systems Integration Testing (SIT) |  |  |  |  |  |  |  |  |
| 1095 | 1.4.1.4.5.3.1 | **Theme 1** |  | 108d | 2024-04-10 A | 2024-09-06 A |  | 100% |  | 2024-04-10 | 2024-09-06 | 96d |  |  |  |  |  | -0 | N/A | N/A | 6.0 | N/A | Systems Integration Testing (SIT) |  |  | -448.67 |  |  |  |  |  |
| 1096 | 1.4.1.4.5.3.1.1 | Develop Test Scenarios & Test Cases |  | 53d | 2024-04-10 A | 2024-06-21 A | 1087 | 100% |  | 2024-04-10 | 2024-06-21 | 16d |  |  |  |  |  |  | SI Test | SI Test, PP | 6.0 |  |  | Complete | COMPLETE |  |  |  |  |  |  |
| 1097 | 1.4.1.4.5.3.1.2 | Industry Review Workshop |  | 1d | 2024-06-24 A | 2024-06-24 A | 1096 | 100% |  | 2024-06-24 | 2024-06-24 | 1d |  |  |  |  |  |  | SI Test, PP | SI Test, PP | 6.0 |  |  | Complete | COMPLETE |  |  |  |  |  |  |
| 1098 | 1.4.1.4.5.3.1.3 | Industry Consultation Review |  | 6d | 2024-07-02 A | 2024-07-09 A | 1097FS+17d | 100% |  | 2024-07-02 | 2024-07-09 | 6d |  |  |  |  |  |  | SI Test, PP | SI Test, PP | 6.0 |  |  | Complete | COMPLETE |  |  |  |  |  |  |
| 1099 | 1.4.1.4.5.3.1.4 | Review with SIT Working Group |  | 5d | 2024-08-19 A | 2024-08-23 A | 1098FS+16d | 100% |  | 2024-08-19 | 2024-08-23 | 5d |  |  |  |  |  |  | SI Test, PP | SI Test, PP | 6.0 |  |  | Complete | COMPLETE |  |  |  |  |  |  |
| 1100 | 1.4.1.4.5.3.1.5 | SIT Operational Scenarios & Test Cases Approved - Theme 1 | milestone | 0d | 2024-09-06 A | 2024-09-06 A | 1099FS+10d | 100% |  | 2024-09-06 | 2024-09-06 | 0d |  |  |  |  | start no earlier than 2024-09-06 |  | SI Test | SI Test, PP | 6.0 | Roger Robar | Systems Integration Testing (SIT) | Complete | COMPLETE |  | T3-TE-0117 | SITAG |  |  | 31/7/24: baseline date change approved at esitag on 26/7/24 |
| 1101 | 1.4.1.4.5.3.2 | **Theme 2** |  | 107d | 2024-04-10 A | 2024-09-06 A |  | 100% |  | 2024-04-10 | 2024-09-06 | 71d |  |  |  |  |  |  | N/A | N/A | 6.0 | N/A | Systems Integration Testing (SIT) |  |  | -448.67 |  |  |  |  |  |
| 1102 | 1.4.1.4.5.3.2.1 | Develop Test Scenarios & Test Cases |  | 53d | 2024-04-10 A | 2024-06-21 A | 1087 | 100% |  | 2024-04-10 | 2024-06-21 | 31d |  |  |  |  | finish no earlier than 2024-06-21 |  | SI Test | SI Test, PP | 6.0 |  |  | Complete | COMPLETE |  |  |  |  |  |  |
| 1103 | 1.4.1.4.5.3.2.2 | Industry Review Workshop |  | 1d | 2024-06-24 A | 2024-06-24 A | 1102 | 100% |  | 2024-06-24 | 2024-06-24 | 1d |  |  |  |  |  |  | SI Test, PP | SI Test, PP | 6.0 |  |  | Complete | COMPLETE |  |  |  |  |  |  |
| 1104 | 1.4.1.4.5.3.2.3 | Industry Consultation Review |  | 6d | 2024-07-02 A | 2024-07-09 A | 1103FS+7d | 100% |  | 2024-07-02 | 2024-07-09 | 6d |  |  |  |  |  |  | SI Test, PP | SI Test, PP | 6.0 |  |  | Complete | COMPLETE |  |  |  |  |  |  |
| 1105 | 1.4.1.4.5.3.2.4 | Review with SIT Working Group |  | 5d | 2024-08-19 A | 2024-08-23 A | 1104FS+11d | 100% |  | 2024-08-19 | 2024-08-23 | 5d |  |  |  |  |  |  | SI Test, PP | SI Test, PP | 6.0 |  |  | Complete | COMPLETE |  |  |  |  |  |  |
| 1106 | 1.4.1.4.5.3.2.5 | SIT Operational Scenarios & Test Cases Approved - Theme 2 | milestone | 0d | 2024-09-06 A | 2024-09-06 A | 1105FS+10d | 100% |  | 2024-09-06 | 2024-09-06 | 0d |  |  |  |  |  |  | SI Test | SI Test, PP | 6.0 |  | Systems Integration Testing (SIT) | Complete | COMPLETE |  | T3-TE-0118 | SITAG |  |  |  |

Notes:
- 1082: Date missed due to lower than expected SIT functional test velocity. Forecast date updated and will be baselined once CR55 is approved.
- 1089: 26/3 - At risk because of tight delivery schedule
- 1096: 12/09/24 - Duration increased from 16 days to 53 days, in line with the SI Plan
- 1097: 12/09/24 - Forecast date changed in line with SI Plan.
- 1098: 12/09/24 - Forecast date changed in line with SI Plan.
- 1099: 12/09/24 - Forecast date changed in line with SI Plan.
- 1100: 12/09/24 - Lag reduced from 35 days to 10 days in line with the SI Plan. Confirmed with Roger R that this is complete.
- 1102: 12/09/24 - Duration increased from 31 days to 53 days, in line with the SI Plan
- 1103: 12/09/24 - Forecast date changed in line with SI Plan.
- 1104: 12/09/24 - Forecast date changed in line with SI Plan.
- 1105: 12/09/24 - Forecast date changed in line with SI Plan.
- 1106: 23/1 - New milestone added because of Operational themed delivery approach. To go to April SITAG for approval. 17/4: Approved as new milestone at SITAG on 17/4/24. Roger R confirmed this is complete.

| ID | WBS | Task | Type | Duration | Start | Finish | Predecessors | Complete | Remaining | Baseline start | Baseline finish | Baseline duration | Total slack | Free slack | Constraint | Baseline cost | Task Status | Update Version | Sched Status | RAG | Responsible | Involved | MHHS Resource Name | MHHS Programme Phase | Guidance | Milestone ID | Text29 |
| --- | --- | --- | --- | --- | --- | --- | --- | --- | --- | --- | --- | --- | --- | --- | --- | --- | --- | --- | --- | --- | --- | --- | --- | --- | --- | --- | --- |
| 1107 | 1.4.1.4.5.3.3 | **Elexon / Helix Service Management Test Prep** |  | 145d? | 2024-07-15 | 2025-01-31 |  |  |  | 2024-07-15 | 2025-01-31 |  | 115d |  |  |  | -688.67 | 6.0 | Overdue Start | RED |  |  |  |  |  |  |  |
| 1108 | 1.4.1.4.5.3.3.1 | Elexon Service Now Build and Implementation |  | 145d? | 2024-07-15 | 2025-01-31 |  |  |  | 2024-07-15 | 2025-01-31 |  | 115d | 0d | start no earlier than 2024-07-15 |  | -94.67 | 6.0 | Overdue Start | GREEN |  |  |  |  |  |  |  |
| 1109 | 1.4.1.4.5.3.3.2 | Helix Engagement and Comms |  | 105d? | 2024-09-09 | 2025-01-31 |  |  |  | 2024-09-09 | 2025-01-31 |  | 115d | 0d | start no earlier than 2024-09-09 |  | -38.67 | 6.0 | Green | GREEN |  |  |  |  |  |  |  |
| 1110 | 1.4.1.4.5.3.3.3 | Helix Service Management Documentation (Service Design Pack and Service User Op Model) |  | 105d? | 2024-09-09 | 2025-01-31 |  |  |  | 2024-09-09 | 2025-01-31 |  | 115d | 0d | start no earlier than 2024-09-09 |  | -38.67 | 6.0 | Green | GREEN |  |  |  |  |  |  |  |
| 1111 | 1.4.1.4.5.3.3.4 | Helix Knowledge Articles |  | 105d? | 2024-09-09 | 2025-01-31 |  |  |  | 2024-09-09 | 2025-01-31 |  | 115d | 0d | start no earlier than 2024-09-09 |  | -38.67 | 6.0 | Green | GREEN |  |  |  |  |  |  |  |
| 1112 | 1.4.1.4.5.3.4 | **Theme 3 (Batch 2)** |  | 60d? | 2024-09-19 A | 2024-12-11 |  | 26% | 44.65d? | 2024-09-19 | 2024-12-11 | 116d | 791d |  |  | -0 | -448.67 | 6.0 |  |  | N/A | N/A | N/A | Systems Integration Testing (SIT) |  |  |  |
| 1113 | 1.4.1.4.5.3.4.1 | Conclude BCDR Scope with SRO, Code Bodies and DIP Manager |  | 22d | 2024-09-19 A | 2024-10-18 |  | 50% | 11d | 2024-09-19 | 2024-10-18 |  | 829d |  | start no earlier than 2024-09-19 |  |  | 6.0 | Green | GREEN |  |  |  |  |  |  |  |
| 1114 | 1.4.1.4.5.3.4.2 | Develop BDCR Test Scenarios & Test Cases (Batch 2) |  | 10d | 2024-10-14 A | 2024-10-25 A | 1113 | 100% |  | 2024-10-14 | 2024-10-25 | 0d |  |  |  |  |  | 6.0 | Complete | COMPLETE |  |  |  |  |  |  |  |
| 1115 | 1.4.1.4.5.3.4.3 | Develop DIP Test Scenarios and Test Cases (Batch 2) |  | 27d | 2024-09-19 | 2024-10-25 |  |  |  | 2024-09-19 | 2024-10-25 |  | 1d | 0d | start no earlier than 2024-09-19 |  | -28.67 | 6.0 | Green | GREEN |  |  |  |  |  |  |  |
| 1116 | 1.4.1.4.5.3.4.4 | SRO Review |  | 5d | 2024-10-28 | 2024-11-01 | 1115 |  |  | 2024-10-28 | 2024-11-01 |  | 1d | 0d | start no earlier than 2024-10-28 |  | 10.33 | 6.0 | Green | GREEN |  |  |  |  |  |  |  |
| 1117 | 1.4.1.4.5.3.4.5 | Industry Review Workshop (Batch 2) |  | 10d | 2024-11-04 A | 2024-11-15 | 1116 | 10% | 9d | 2024-11-04 | 2024-11-15 | 1d | 94d | 0d |  |  |  | 6.0 | Green | GREEN | SI Test, PP | SI Test, PP |  |  |  |  |  |
| 1118 | 1.4.1.4.5.3.4.6 | Review Feedback and Update |  | 5d | 2024-11-18 | 2024-11-22 | 1117 |  |  | 2024-11-18 | 2024-11-22 |  | 94d | 0d |  |  | 31.33 | 6.0 | Green | GREEN |  |  |  |  |  |  |  |
| 1119 | 1.4.1.4.5.3.4.7 | Review with SIT WG (Batch 2) |  | 6d | 2024-11-28 | 2024-12-05 | 1118FS+3d |  |  | 2024-11-28 | 2024-12-05 |  | 94d | 0d |  |  | 41.33 | 6.0 | Green | GREEN |  |  |  |  |  |  |  |
| 1120 | 1.4.1.4.5.3.4.8 | SITAG Approval (Batch 2) |  | 1d? | 2024-12-11 | 2024-12-11 | 1119FS+3d |  |  | 2024-12-11 | 2024-12-11 |  | 94d | 0d |  |  | 54.33 | 6.0 | Green | GREEN |  |  |  |  |  |  |  |
| 1121 | 1.4.1.4.5.3.5 | **Theme 3 (Batch 1)** |  | 176d? | 2024-04-10 A | 2024-12-11 |  | 75% | 44.33d? | 2024-04-10 | 2024-12-11 |  | 94d |  |  |  | -688.67 | 6.0 | Overdue Start | RED |  |  |  |  |  |  |  |
| 1122 | 1.4.1.4.5.3.5.1 | Develop Test Scenarios & Test Cases (Batch 1) |  | 78d | 2024-04-10 A | 2024-07-26 A | 1087 | 100% |  | 2024-04-10 | 2024-07-26 | 46d |  |  |  |  |  | 6.0 | Complete | COMPLETE | SI Test | SI Test, PP |  |  |  |  |  |
| 1123 | 1.4.1.4.5.3.5.2 | Conclude Industry Consultation (Batch 1) |  | 11d | 2024-09-05 A | 2024-09-19 A |  | 100% |  | 2024-09-05 | 2024-09-19 |  |  |  | start no earlier than 2024-09-05 |  |  | 6.0 | Complete | COMPLETE |  |  |  |  |  |  |  |
| 1124 | 1.4.1.4.5.3.5.3 | Review Feedback and Update |  | 5d | 2024-09-20 A | 2024-09-26 | 1123 | 90% | 0.5d | 2024-09-20 | 2024-09-26 |  | 7.5d | 0d |  |  |  | 6.0 | Green | GREEN |  |  |  |  |  |  |  |
| 1125 | 1.4.1.4.5.3.5.4 | Draft Test Cases from Feedback and LLSD |  | 15d? | 2024-09-30 A | 2024-10-18 | 1124FS+1d, 1134 | 50% | 7.5d? | 2024-09-30 | 2024-10-18 |  | 94d | 0d |  |  |  | 6.0 | Green | GREEN |  |  |  |  |  |  |  |
| 1126 | 1.4.1.4.5.3.5.5 | SRO Review |  | 5d? | 2024-10-21 | 2024-10-25 | 1125 |  |  | 2024-10-21 | 2024-10-25 |  | 94d | 0d |  |  | 3.33 | 6.0 | Green | GREEN |  |  |  |  |  |  |  |
| 1127 | 1.4.1.4.5.3.5.6 | Industry Consultation |  | 10d? | 2024-10-28 | 2024-11-08 | 1126 |  |  | 2024-10-28 | 2024-11-08 |  | 94d | 0d |  |  | 10.33 | 6.0 | Green | GREEN |  |  |  |  |  |  |  |
| 1128 | 1.4.1.4.5.3.5.7 | Review Feedback and Update |  | 5d | 2024-11-11 | 2024-11-15 | 1127 |  |  | 2024-11-11 | 2024-11-15 |  | 94d | 0d |  |  | 24.33 | 6.0 | Green | GREEN |  |  |  |  |  |  |  |
| 1129 | 1.4.1.4.5.3.5.8 | Review with SITWG (Batch 1) |  | 5d? | 2024-11-28 | 2024-12-04 | 1128FS+8d |  |  | 2024-11-28 | 2024-12-04 |  | 94d | 0d |  |  | 41.33 | 6.0 | Green | GREEN |  |  |  |  |  |  |  |
| 1130 | 1.4.1.4.5.3.5.9 | SITAG for approval (Batch 1) |  | 1d | 2024-12-11 | 2024-12-11 | 1129FS+4d |  |  | 2024-12-11 | 2024-12-11 |  | 94d | 0d |  |  | 54.33 | 6.0 | Green | GREEN |  |  |  |  |  |  |  |
| 1131 | 1.4.1.4.5.3.5.10 | SIT Operational Scenarios & Test Cases Approved - Theme 3 (Batch 1 + 2) | milestone | 0d | 2024-12-11 | 2024-12-11 | 1134, 1120, 1130 |  |  | 2024-12-11 | 2024-12-11 | 0d | 94d | 0d |  |  | 54.71 | 6.0 | Green | AMBER | SI Test | SI Test, PP | Roger Robar | Systems Integration Testing (SIT) | 31/7/24: baseline date change approved at esitag on 26/7/24 | T3-TE-0119 | SITAG |

Notes:
- 1114: 12/09/24 - Added new milestone for Batch 2
- 1117: 12/09/24 - Forecast date changed in line with SI Plan.
- 1122: 12/09/24 - Duration increased from 46 days to 78 days to reflect the SI Plan.
- 1131: Date missed. Still working LLSD feedback and clarifications requested. Once this has been completed, test cases can be drafted and submitted.

| ID | WBS | Task | Type | Duration | Start | Finish | Predecessors | Complete | Remaining | Baseline start | Baseline finish | Baseline duration | Baseline 1 start | Baseline 1 finish | Total slack | Free slack | Constraint | Baseline cost | Task Status | Update Version | Sched Status | RAG | Responsible | Involved | MHHS Resource Name | MHHS Programme Phase | Milestone ID | Text29 | Tier |
| --- | --- | --- | --- | --- | --- | --- | --- | --- | --- | --- | --- | --- | --- | --- | --- | --- | --- | --- | --- | --- | --- | --- | --- | --- | --- | --- | --- | --- | --- |
| 1132 | 1.4.1.4.5.3.6 | **Helix SDD and LLSD Development and Approval** |  | 1d | 2024-09-27 | 2024-09-30 |  |  |  | 2024-09-27 | 2024-09-30 |  |  |  | 8.5d |  |  |  | -688.67 | 6.0 | Overdue Start | RED |  |  |  |  |  |  |  |
| 1133 | 1.4.1.4.5.3.6.1 | Development | milestone | 0d | 2024-09-27 | 2024-09-27 |  |  |  | 2024-09-27 | 2024-09-27 |  |  |  | 845d |  | start no earlier than 2024-09-27 |  | -20.67 | 6.0 | Green | GREEN |  |  |  |  |  |  |  |
| 1134 | 1.4.1.4.5.3.6.2 | Approval | milestone | 0d | 2024-09-30 | 2024-09-30 |  |  |  | 2024-09-30 | 2024-09-30 |  |  |  | 7.5d | 0d | start no earlier than 2024-09-30 |  | -17.67 | 6.0 | Green | GREEN |  |  |  |  |  |  |  |
| 1135 | 1.4.1.4.5.4 | **SIT Operational Programme RTTM** |  | 27d? | 2024-12-12 | 2025-01-17 |  |  |  | 2024-12-12 | 2025-01-17 |  |  |  | 764d |  |  |  | -686.67 | 6.0 | Overdue Start | RED |  |  |  |  |  |  |  |
| 1136 | 1.4.1.4.5.4.1 | Develop Manual SIT Operational RTTM |  | 22d? | 2024-12-12 | 2025-01-10 | 1131 |  |  | 2024-12-12 | 2025-01-10 |  |  |  | 764d | 0d |  |  | 55.33 | 6.0 | Green | GREEN |  |  |  |  |  |  |  |
| 1137 | 1.4.1.4.5.4.2 | Manual SIT Operational RTTM Complete | milestone | 0d | 2025-01-10 | 2025-01-10 | 1136 |  |  | 2025-01-10 | 2025-01-10 |  |  |  | 769d |  |  |  | 84.71 | 6.0 | Green | GREEN |  |  |  |  |  |  |  |
| 1138 | 1.4.1.4.5.4.3 | Develop Automated SIT Operational RTTM |  | 5d | 2025-01-13 | 2025-01-17 | 1136 |  |  | 2025-01-13 | 2025-01-17 |  |  |  | 764d | 0d |  |  | 87.33 | 6.0 | Green | GREEN |  |  |  |  |  |  |  |
| 1139 | 1.4.1.4.5.4.4 | Automated SIT Operational RTTM Complete | milestone | 0d | 2025-01-17 | 2025-01-17 | 1138 |  |  | 2025-01-17 | 2025-01-17 |  |  |  | 764d |  |  |  | 91.71 | 6.0 | Green | GREEN |  |  |  |  |  |  |  |
| 1140 | 1.4.1.4.5.5 | **Environments (SIT B)** |  | 0d | 2024-10-07 | 2024-10-07 |  |  |  | 2024-10-07 | 2024-10-07 | 0d | 2024-09-03 | 2024-09-09 | 38d |  |  | -0 |  | 5.0 |  |  | N/A | N/A | N/A | Systems Integration Testing (SIT) |  |  |  |
| 1141 | 1.4.1.4.5.5.1 | **PP Environments (SIT B)** |  | 0d | 2024-10-07 | 2024-10-07 |  |  |  | 2024-10-07 | 2024-10-07 | 0d | 2024-09-03 | 2024-09-09 | 38d |  |  | -0 |  | 5.0 |  |  | N/A | N/A | N/A | Systems Integration Testing (SIT) |  |  |  |
| 1142 | 1.4.1.4.5.5.1.1 | Deployment of MHHS solution code to SIT B environments | milestone | 0d | 2024-10-07 | 2024-10-07 | 141 |  |  | 2024-10-07 | 2024-10-07 | 0d | 2024-09-03 | 2024-09-09 | 38d | 0d | start no earlier than 2024-08-27 |  | -10.67 | 5.21 | Green | GREEN | PP | SI Test | Heath Thomas | Systems Integration Testing (SIT) |  |  |  |
| 1143 | 1.4.1.4.5.5.2 | **SI Environments (SIT B)** |  | 0d | 2024-10-07 | 2024-10-07 |  |  |  | 2024-10-07 | 2024-10-07 | 0d | 2024-09-03 | 2024-09-09 | 38d |  |  | -0 |  | 5.0 |  |  | N/A | N/A | N/A | Systems Integration Testing (SIT) |  |  |  |
| 1144 | 1.4.1.4.5.5.2.1 | Coordinate deployment of MHHS solution code to SIT Participants' SIT B environments | milestone | 0d | 2024-10-07 | 2024-10-07 | 1142SS |  |  | 2024-10-07 | 2024-10-07 | 0d | 2024-09-03 | 2024-09-09 | 38d | 0d |  |  | -10.67 | 5.21 | Green | GREEN | SI Test | PP | Heath Thomas | Systems Integration Testing (SIT) |  |  |  |
| 1145 | 1.4.1.4.6 | **SIT Operational Test Readiness Report** |  | 33d | 2024-08-05 | 2024-09-18 |  |  |  | 2024-08-05 | 2024-09-18 | 151d | 2025-01-07 | 2025-03-03 |  |  |  | -0 |  | 6.0 |  |  | N/A | N/A | N/A | Systems Integration Testing (SIT) |  |  |  |
| 1146 | 1.4.1.4.6.1 | **PP SIT Operational Test Readiness Report** |  | 0d | 2024-08-05 | 2024-08-05 |  |  |  | 2024-08-05 | 2024-08-05 | 131d | 2025-01-07 | 2025-02-17 |  |  |  | -0 |  | 6.0 |  |  | N/A | N/A | N/A | Systems Integration Testing (SIT) |  |  |  |
| 1147 | 1.4.1.4.6.1.1 | Test Readiness Report submitted to Programme for assurance | milestone | 0d | 2024-08-05 | 2024-08-05 |  |  |  | 2024-08-05 | 2024-08-05 | 20d | 2025-01-07 | 2025-02-03 | 769d | 0d | start no earlier than 2024-08-05 |  | -73.67 | 6.0 | Overdue Start | RED | PP | SI Test | Roger Robar | Systems Integration Testing (SIT) |  |  |  |
| 1148 | 1.4.1.4.6.2 | **SI SIT Operational Test Readiness Report** |  | 120d | 2024-08-05 | 2025-01-17 |  |  |  | 2024-08-05 | 2025-01-17 | 40d | 2025-01-07 | 2025-03-03 | 152d |  |  |  |  | 5.0 |  |  | N/A | N/A | N/A | Systems Integration Testing (SIT) |  |  |  |
| 1149 | 1.4.1.4.6.2.1 | Assure Test Participants' Test Readiness Reports |  | 115d | 2024-08-05 | 2025-01-10 | 1147 |  |  | 2024-08-05 | 2025-01-10 | 35d | 2025-01-07 | 2025-02-24 | 769d |  |  |  | -73.67 | 6.0 | Overdue Start | GREEN | SI Test | PP,IPA | Roger Robar | Systems Integration Testing (SIT) |  |  |  |
| 1150 | 1.4.1.4.6.2.2 | Develop Overarching SIT Operational Test Readiness Report |  | 30d | 2024-12-02 | 2025-01-10 |  |  |  | 2024-12-02 | 2025-01-10 | 20d | 2025-01-28 | 2025-02-24 | 67d | 0d | start no earlier than 2024-12-02 |  | 45.33 | 6.0 | Green | GREEN | SI Test |  | Roger Robar | Systems Integration Testing (SIT) |  |  |  |
| 1151 | 1.4.1.4.6.2.3 | Artefact review (via SITAG) and updates |  | 5d | 2025-01-13 | 2025-01-17 | 1150 |  |  | 2025-01-13 | 2025-01-17 | 5d | 2025-02-25 | 2025-03-03 | 67d | 0d |  |  | 87.33 | 5.0 | Green | GREEN | SI Test | PP,IPA | Roger Robar | Systems Integration Testing (SIT) |  |  |  |
| 1152 | 1.4.1.4.6.3 | SIT Operational Testing Preparation Complete | milestone | 0d | 2025-01-17 | 2025-01-17 | 402, 1100, 1106, 1131, 1151 |  |  | 2025-01-17 | 2025-01-17 | 0d | 2025-03-10 | 2025-03-10 | 67d | 7d | finish no earlier than 2024-10-04 |  | 91.71 | 6.0 | Green | AMBER | SI Test | PP,IPA | Roger Robar | Systems Integration Testing (SIT) | T2-TE-0750 | SITAG | T2 |
| 1153 | 1.4.1.4.7 | **Regression Test Preperation** |  | 175d? | 2024-09-16 A | 2025-05-16 |  | 3% | 169.73d? | 2024-09-16 | 2025-05-16 |  |  |  | 679d |  |  |  | -686.67 | 6.1 | Overdue Start | RED |  |  |  |  |  |  |  |
| 1154 | 1.4.1.4.7.1 | **Regression Test Approach** |  | 48d | 2024-09-16 A | 2024-11-20 |  | 7% | 44.48d | 2024-09-16 | 2024-11-20 |  |  |  | 119d |  |  |  | -686.67 | 6.1 | Overdue Start | RED |  |  |  |  |  |  |  |
| 1155 | 1.4.1.4.7.1.1 | Develop approach doc |  | 22d | 2024-09-16 A | 2024-10-15 |  | 10% | 19.8d | 2024-09-16 | 2024-10-15 |  |  |  | 119d | 0d | start no earlier than 2024-09-16 |  |  | 6.1 | Green | RED |  |  |  |  |  |  |  |
| 1156 | 1.4.1.4.7.1.2 | SRO review of approach doc |  | 3d | 2024-10-16 | 2024-10-18 | 1155 |  |  | 2024-10-16 | 2024-10-18 |  |  |  | 119d | 0d |  |  | -1.67 | 6.1 | Green | GREEN |  |  |  |  |  |  |  |
| 1157 | 1.4.1.4.7.1.3 | SITWG feedback on approach doc |  | 2d | 2024-10-28 | 2024-10-29 | 1156FS+5d |  |  | 2024-10-28 | 2024-10-29 |  |  |  | 119d | 0d |  |  | 10.33 | 6.1 | Green | GREEN |  |  |  |  |  |  |  |
| 1158 | 1.4.1.4.7.1.4 | Incorporate SRO + SITWG feedback into approach doc |  | 2d | 2024-10-30 | 2024-10-31 | 1157 |  |  | 2024-10-30 | 2024-10-31 |  |  |  | 119d | 0d |  |  | 12.33 | 6.1 | Green | GREEN |  |  |  |  |  |  |  |
| 1159 | 1.4.1.4.7.1.5 | SITWG Recommendation |  | 1d | 2024-11-07 | 2024-11-07 | 1158FS+4d |  |  | 2024-11-07 | 2024-11-07 |  |  |  | 119d | 0d |  |  | 20.33 | 6.1 | Green | GREEN |  |  |  |  |  |  |  |
| 1160 | 1.4.1.4.7.1.6 | SITAG (inc SRO) Approval | milestone | 0d | 2024-11-20 | 2024-11-20 | 1159FS+9d |  |  | 2024-11-20 | 2024-11-20 |  |  |  | 119d | 0d |  |  | 33.71 | 6.1 | Green | GREEN |  |  |  |  |  |  |  |
| 1161 | 1.4.1.4.7.1.7 | SIT Regression Testing Approach and Plan Approval | milestone | 0d | 2024-11-20 | 2024-11-20 | 1160 |  |  | 2024-11-20 | 2024-11-20 |  |  |  | 119d | 0d |  |  | 33.71 | 6.1 | Green | GREEN |  |  |  |  | T3-TE-0123 |  |  |

Notes:
- 1145: 12/09/24 - Forecast start date brought forward to 05/08/24, duration extended from 19 days to 33 days in line with the SI Plan.
- 1146: 12/09/24 - Forecast start date brought forward to 05/08/24 in line with the SI Plan.
- 1147: 12/09/24 - Forecast start date brought forward to 05/08/24 in line with the SI Plan.
- 1149: 12/09/24 - Duration increased from 5 days to 25 days in line with the SI Plan.
- 1150: 12/09/24 - Duration increased from 4 days to 18 days in line with the SI Plan.
- 1152: Date missed because of delay to submissions for SIT Operational PIT completion reports. Impact may be a delay to the start of SIT Operational Testing. Continue engagement with PPs.

| ID | WBS | Task | Type | Duration | Start | Finish | Predecessors | Complete | Remaining | Baseline start | Baseline finish | Total slack | Free slack | Constraint | Task Status | Update Version | Sched Status | RAG | Milestone ID | Programme Governance Forum responsible for decisio | Text29 | MHHS Resource Name |
| --- | --- | --- | --- | --- | --- | --- | --- | --- | --- | --- | --- | --- | --- | --- | --- | --- | --- | --- | --- | --- | --- | --- |
| 1162 | 1.4.1.4.7.2 | **Regression Test Suite** |  | 38d? | 2024-11-21 | 2025-01-13 |  |  |  | 2024-11-21 | 2025-01-13 | 119d |  |  | -686.67 | 6.1 | Overdue Start | RED |  |  |  |  |
| 1163 | 1.4.1.4.7.2.1 | Build Regression Test Suite |  | 12d | 2024-11-21 | 2024-12-06 | 1161 |  |  | 2024-11-21 | 2024-12-06 | 119d | 0d |  | 34.33 | 6.1 | Green | GREEN |  |  |  |  |
| 1164 | 1.4.1.4.7.2.2 | SRO Review of regression suite doc |  | 10d | 2024-12-09 | 2024-12-20 | 1163 |  |  | 2024-12-09 | 2024-12-20 | 119d | 0d |  | 52.33 | 6.1 | Green | GREEN |  |  |  |  |
| 1165 | 1.4.1.4.7.2.3 | SITWG Feedback on regression suite doc |  | 5d | 2024-12-30 | 2025-01-03 | 1164FS+5d |  |  | 2024-12-30 | 2025-01-03 | 119d | 0d |  | 73.33 | 6.1 | Green | GREEN |  |  |  |  |
| 1166 | 1.4.1.4.7.2.4 | Incorporate SRO + SITWG feedback into regression suite doc |  | 1d? | 2025-01-06 | 2025-01-06 | 1165 |  |  | 2025-01-06 | 2025-01-06 | 119d | 0d |  | 80.33 | 6.1 | Green | GREEN |  |  |  |  |
| 1167 | 1.4.1.4.7.2.5 | SRO Approval | milestone | 0d | 2025-01-06 | 2025-01-06 | 1166 |  |  | 2025-01-06 | 2025-01-06 | 119d | 0d |  | 80.71 | 6.1 | Green | GREEN |  |  |  |  |
| 1168 | 1.4.1.4.7.2.6 | SIT Regression Suite Approval at SITAG | milestone | 0d | 2025-01-13 | 2025-01-13 | 1167FS+5d |  |  | 2025-01-13 | 2025-01-13 | 768d |  |  | 87.71 | 6.1 | Green | GREEN | T3-TE-0122 | SITAG | SITAG |  |
| 1169 | 1.4.1.4.7.3 | **Regression Test Data Load Window (SIT Functional and Migration) - SIT A** |  | 1d? | 2025-03-14 | 2025-03-17 |  |  |  | 2025-03-14 | 2025-03-17 |  |  |  | -686.67 | 6.1 | Overdue Start | RED |  |  |  |  |
| 1170 | 1.4.1.4.7.3.1 | Regression Test Data Load Start | milestone | 0d? | 2025-04-28 | 2025-04-28 | 1309, 1267FS+1d, 1313FS+1d |  |  | 2025-04-28 | 2025-04-28 | 5d | 0d |  | 192.71 | 6.1 | Green | GREEN |  |  |  |  |
| 1171 | 1.4.1.4.7.3.2 | Regression Test Data Load Window |  | 15d? | 2025-04-28 | 2025-05-16 | 1170FS-1d |  |  | 2025-04-28 | 2025-05-16 | 5d | 0d |  | 192.33 | 6.1 | Green | GREEN |  |  |  |  |
| 1172 | 1.4.1.4.8 | **Single Instance ADO** |  | 32d? | 2024-08-21 A | 2024-10-03 |  | 86% | 4.32d? | 2024-08-21 | 2024-10-03 | 840d |  |  | -701.67 | 6.1 | Overdue Start | RED |  |  |  | Heath Thomas |
| 1173 | 1.4.1.4.8.1 | **Single ADO Project for all Cohorts - Implementation and Test Phase** |  | 30d? | 2024-08-21 A | 2024-10-01 |  | 89% | 3.21d? | 2024-08-21 | 2024-10-01 | 842d |  |  | -701.67 | 6.1 | Overdue Start | RED |  |  |  | Heath Thomas |
| 1174 | 1.4.1.4.8.1.1 | Create test plans and suites in master project |  | 2d? | 2024-08-21 A | 2024-08-22 A |  | 100% |  | 2024-08-21 | 2024-08-22 |  |  | finish no earlier than 2024-08-22 |  | 6.1 | Complete | COMPLETE |  |  |  |  |
| 1175 | 1.4.1.4.8.1.2 | Create area paths / iterations |  | 2d? | 2024-08-21 A | 2024-08-22 A |  | 100% |  | 2024-08-21 | 2024-08-22 |  |  | finish no earlier than 2024-08-22 |  | 6.1 | Complete | COMPLETE |  |  |  |  |
| 1176 | 1.4.1.4.8.1.3 | Create IAM roles |  | 2d? | 2024-08-21 A | 2024-08-22 A |  | 100% |  | 2024-08-21 | 2024-08-22 |  |  | finish no earlier than 2024-08-22 |  | 6.1 | Complete | COMPLETE |  |  |  |  |
| 1177 | 1.4.1.4.8.1.4 | Add users to roles |  | 1d? | 2024-08-23 A | 2024-08-23 A |  | 100% |  | 2024-08-23 | 2024-08-23 |  |  | start no earlier than 2024-08-23 |  | 6.1 | Complete | COMPLETE |  |  |  |  |
| 1178 | 1.4.1.4.8.1.5 | **Testing permissions** |  | 2d? | 2024-08-27 A | 2024-08-28 A |  | 100% |  | 2024-08-27 | 2024-08-28 |  |  |  |  | 6.1 | Complete | COMPLETE |  |  |  | Heath Thomas |
| 1179 | 1.4.1.4.8.1.5.1 | Adding tests |  | 2d? | 2024-08-27 A | 2024-08-28 A |  | 100% |  | 2024-08-27 | 2024-08-28 |  |  | finish no earlier than 2024-08-28 |  | 6.1 | Complete | COMPLETE |  |  |  |  |
| 1180 | 1.4.1.4.8.1.5.2 | Deleting tests |  | 2d? | 2024-08-27 A | 2024-08-28 A |  | 100% |  | 2024-08-27 | 2024-08-28 |  |  | finish no earlier than 2024-08-28 |  | 6.1 | Complete | COMPLETE |  |  |  |  |
| 1181 | 1.4.1.4.8.1.5.3 | Adding tests to incorrect Cohort |  | 2d? | 2024-08-27 A | 2024-08-28 A |  | 100% |  | 2024-08-27 | 2024-08-28 |  |  | finish no earlier than 2024-08-28 |  | 6.1 | Complete | COMPLETE |  |  |  |  |
| 1182 | 1.4.1.4.8.1.5.4 | Add / delete defects |  | 2d? | 2024-08-27 A | 2024-08-28 A |  | 100% |  | 2024-08-27 | 2024-08-28 |  |  | finish no earlier than 2024-08-28 |  | 6.1 | Complete | COMPLETE |  |  |  |  |
| 1183 | 1.4.1.4.8.1.6 | Migrate defects from cohort project to master - Option 2 |  | 3d | 2024-09-23 | 2024-09-25 |  |  |  | 2024-09-23 | 2024-09-25 | 846d |  | start no earlier than 2024-09-23 | -24.67 | 6.1 | Green | RED |  |  |  |  |
| 1184 | 1.4.1.4.8.1.7 | Testing Permissions - Evidence attachment security |  | 10d? | 2024-09-18 A | 2024-10-01 A |  | 100% |  | 2024-09-18 | 2024-10-01 |  |  | finish no earlier than 2024-10-01 |  | 6.1 | Complete | COMPLETE |  |  |  |  |
| 1185 | 1.4.1.4.8.2 | **ADO Dashboard Updates** |  | 20d? | 2024-09-03 A | 2024-09-30 A |  | 100% |  | 2024-09-03 | 2024-09-30 |  |  |  | -701.67 | 6.1 | Overdue Start | RED |  |  |  | Heath Thomas |
| 1186 | 1.4.1.4.8.2.1 | Update reporting dashboards in ADO |  | 3d | 2024-09-03 A | 2024-09-05 A |  | 100% |  | 2024-09-03 | 2024-09-05 |  |  | start no earlier than 2024-09-03 |  | 6.1 | Complete | COMPLETE |  |  |  |  |
| 1187 | 1.4.1.4.8.2.2 | Review dashboards with SI LDP leads |  | 16d | 2024-09-06 A | 2024-09-27 A |  | 100% |  | 2024-09-06 | 2024-09-27 |  |  | start no earlier than 2024-09-06 |  | 6.1 | Complete | COMPLETE |  |  |  |  |
| 1188 | 1.4.1.4.8.2.3 | Review dashboards with SRO |  | 16d | 2024-09-09 A | 2024-09-30 A |  | 100% |  | 2024-09-09 | 2024-09-30 |  |  | start no earlier than 2024-09-09 |  | 6.1 | Complete | COMPLETE |  |  |  |  |
| 1189 | 1.4.1.4.8.2.4 | Update dashboards following review |  | 2d | 2024-09-12 A | 2024-09-13 A |  | 100% |  | 2024-09-12 | 2024-09-13 |  |  | start no earlier than 2024-09-12 |  | 6.1 | Complete | COMPLETE |  |  |  |  |
| 1190 | 1.4.1.4.8.2.5 | Document changes to dashboard creation process |  | 4d | 2024-09-16 A | 2024-09-19 A |  | 100% |  | 2024-09-16 | 2024-09-19 |  |  | start no earlier than 2024-09-16 |  | 6.1 | Complete | COMPLETE |  |  |  |  |
| 1191 | 1.4.1.4.8.2.6 | Update SIT Dashboards for Sprints 4.1 & 4.2 across all Cohorts |  | 1d? | 2024-09-03 A | 2024-09-03 A |  | 100% |  | 2024-09-03 | 2024-09-03 |  |  | start no earlier than 2024-09-03 |  | 6.1 | Complete | COMPLETE |  |  |  |  |

| ID | WBS | Task | Duration | Start | Finish | Complete | Remaining | Baseline start | Baseline finish | Total slack | Constraint | Task Status | Update Version | Sched Status | MHHS Resource Name | RAG |
| --- | --- | --- | --- | --- | --- | --- | --- | --- | --- | --- | --- | --- | --- | --- | --- | --- |
| 1192 | 1.4.1.4.8.3 | **Reporting Changes - PowerBI & QIP** | 23d? | 2024-08-23 A | 2024-09-24 | 70% | 6.9d? | 2024-08-23 | 2024-09-24 | 847d |  | -701.67 | 6.1 | Overdue Start | Heath Thomas | RED |
| 1193 | 1.4.1.4.8.3.1 | Design, Create and ETL ADO Entities into PowerBI Data Model | 1d? | 2024-08-23 A | 2024-08-23 A | 100% |  | 2024-08-23 | 2024-08-23 |  | start no earlier than 2024-08-23 |  | 6.1 | Complete |  | COMPLETE |
| 1194 | 1.4.1.4.8.3.2 | Determine Relationships between ADO Entities & Attributes | 1d? | 2024-08-27 A | 2024-08-27 A | 100% |  | 2024-08-27 | 2024-08-27 |  | start no earlier than 2024-08-27 |  | 6.1 | Complete |  | COMPLETE |
| 1195 | 1.4.1.4.8.3.3 | Create Relevant Dax Measures | 1d? | 2024-08-28 A | 2024-08-28 A | 100% |  | 2024-08-28 | 2024-08-28 |  | start no earlier than 2024-08-28 |  | 6.1 | Complete |  | COMPLETE |
| 1196 | 1.4.1.4.8.3.4 | Design & Build Visualisations (Graphs) | 1d? | 2024-08-29 A | 2024-08-29 A | 100% |  | 2024-08-29 | 2024-08-29 |  | start no earlier than 2024-08-29 |  | 6.1 | Complete |  | COMPLETE |
| 1197 | 1.4.1.4.8.3.5 | Implement Filters | 1d? | 2024-09-23 A | 2024-09-23 A | 100% |  | 2024-09-23 | 2024-09-23 |  | start no earlier than 2024-09-23 |  | 6.1 | Complete |  | COMPLETE |
| 1198 | 1.4.1.4.8.3.6 | Check Data Quality & Integrity | 1d? | 2024-09-24 A | 2024-09-24 A | 100% |  | 2024-09-24 | 2024-09-24 |  | start no earlier than 2024-09-24 |  | 6.1 | Complete |  | COMPLETE |
| 1199 | 1.4.1.4.8.3.7 | Performance Optimisation | 1d? | 2024-09-24 A | 2024-09-24 A | 100% |  | 2024-09-24 | 2024-09-24 |  | start no earlier than 2024-09-24 |  | 6.1 | Complete |  | COMPLETE |
| 1200 | 1.4.1.4.8.3.8 | Publish (QIP) | 1d? | 2024-09-04 | 2024-09-04 |  |  | 2024-09-04 | 2024-09-04 | 861d | start no earlier than 2024-09-04 | -43.67 | 6.1 | Green |  | RED |
| 1201 | 1.4.1.4.8.3.9 | Review & UAT | 1d? | 2024-09-05 | 2024-09-05 |  |  | 2024-09-05 | 2024-09-05 | 860d | start no earlier than 2024-09-05 | -42.67 | 6.1 | Green |  | RED |
| 1202 | 1.4.1.4.8.3.10 | QIP Training Material & User Guides | 1d? | 2024-09-10 | 2024-09-10 |  |  | 2024-09-10 | 2024-09-10 | 857d | start no earlier than 2024-09-10 | -37.67 | 6.1 | Green |  | RED |
| 1203 | 1.4.1.4.8.4 | **Reporting Changes - Daily Excel Extract & PDF** | 2d | 2024-09-05 | 2024-09-06 |  |  | 2024-09-05 | 2024-09-06 | 859d |  | -701.67 | 6.1 | Overdue Start | Heath Thomas | RED |
| 1204 | 1.4.1.4.8.4.1 | Excel Daily Report changes (Refer to above) | 2d | 2024-09-05 | 2024-09-06 |  |  | 2024-09-05 | 2024-09-06 | 859d | start no earlier than 2024-09-05 | -42.67 | 6.1 | Green |  | RED |
| 1205 | 1.4.1.4.8.4.2 | PDF Daily Report changes (Refer to Above) | 2d | 2024-09-05 | 2024-09-06 |  |  | 2024-09-05 | 2024-09-06 | 859d | start no earlier than 2024-09-05 | -42.67 | 6.1 | Green |  | RED |
| 1206 | 1.4.1.4.8.5 | **Documentation Updates** | 23d? | 2024-09-02 A | 2024-10-02 | 80% | 4.51d? | 2024-09-02 | 2024-10-02 | 841d |  | -701.67 | 6.1 | Overdue Start | Heath Thomas | RED |
| 1207 | 1.4.1.4.8.5.1 | Changes to onboarding process (security) | 10d | 2024-09-02 | 2024-09-13 |  |  | 2024-09-02 | 2024-09-13 | 854d | start no earlier than 2024-09-02 | -45.67 | 6.1 | Green |  | RED |
| 1208 | 1.4.1.4.8.5.2 | Update the documents on loading tests into ADO? | 10d | 2024-09-02 A | 2024-09-13 A | 100% |  | 2024-09-02 | 2024-09-13 |  | start no earlier than 2024-09-02 |  | 6.1 | Complete |  | COMPLETE |
| 1209 | 1.4.1.4.8.5.3 | Update ADO Training material | 10d | 2024-09-02 A | 2024-09-13 A | 100% |  | 2024-09-02 | 2024-09-13 |  | start no earlier than 2024-09-02 |  | 6.1 | Complete |  | COMPLETE |
| 1210 | 1.4.1.4.8.5.4 | Update ADO User Guide | 10d | 2024-09-02 A | 2024-09-13 A | 100% |  | 2024-09-02 | 2024-09-13 |  | start no earlier than 2024-09-02 |  | 6.1 | Complete |  | COMPLETE |
| 1211 | 1.4.1.4.8.5.5 | Update ADO Configuration document | 10d | 2024-09-02 A | 2024-09-13 A | 100% |  | 2024-09-02 | 2024-09-13 |  | start no earlier than 2024-09-02 |  | 6.1 | Complete |  | COMPLETE |
| 1212 | 1.4.1.4.8.5.6 | Update ADO Training Material and User Guide following SRO review | 1d? | 2024-10-02 A | 2024-10-02 A | 100% |  | 2024-10-02 | 2024-10-02 |  | start no earlier than 2024-10-02 |  | 6.1 | Complete |  | COMPLETE |
| 1213 | 1.4.1.4.8.6 | **ADO Changes - Review Stage** | 19d? | 2024-09-09 A | 2024-10-03 A | 100% |  | 2024-09-09 | 2024-10-03 |  |  | -701.67 | 6.1 | Overdue Start | Heath Thomas |  |
| 1214 | 1.4.1.4.8.6.1 | Review implementation with SI LDP leads | 1d? | 2024-09-27 A | 2024-09-27 A | 100% |  | 2024-09-27 | 2024-09-27 |  | start no earlier than 2024-09-27 |  | 6.1 | Complete |  | COMPLETE |
| 1215 | 1.4.1.4.8.6.2 | Review implementation with SRO | 1d? | 2024-09-30 A | 2024-09-30 A | 100% |  | 2024-09-30 | 2024-09-30 |  | start no earlier than 2024-09-30 |  | 6.1 | Complete |  | COMPLETE |
| 1216 | 1.4.1.4.8.6.3 | LDP Review - ADO User Guide, Training Materials | 5d | 2024-09-09 A | 2024-09-13 A | 100% |  | 2024-09-09 | 2024-09-13 |  | start no earlier than 2024-09-09 |  | 6.1 | Complete |  | COMPLETE |
| 1217 | 1.4.1.4.8.6.4 | SRO Review - ADO User Guide, Training Materials | 1d? | 2024-09-30 A | 2024-09-30 A | 100% |  | 2024-09-30 | 2024-09-30 |  | start no earlier than 2024-09-30 |  | 6.1 | Complete |  | COMPLETE |
| 1218 | 1.4.1.4.8.6.5 | LDP Review - Config doc | 1d? | 2024-09-30 A | 2024-09-30 A | 100% |  | 2024-09-30 | 2024-09-30 |  | start no earlier than 2024-09-30 |  | 6.1 | Complete |  | COMPLETE |
| 1219 | 1.4.1.4.8.6.6 | SRO Review - Config doc | 1d? | 2024-09-30 A | 2024-09-30 A | 100% |  | 2024-09-30 | 2024-09-30 |  | start no earlier than 2024-09-30 |  | 6.1 | Complete |  | COMPLETE |
| 1220 | 1.4.1.4.8.6.7 | SRO Sign-off of all changes | 1d? | 2024-10-03 A | 2024-10-03 A | 100% |  | 2024-10-03 | 2024-10-03 |  | start no earlier than 2024-10-03 |  | 6.1 | Complete |  | COMPLETE |

| ID | WBS | Task | Type | Duration | Start | Finish | Predecessors | Complete | Remaining | Baseline start | Baseline finish | Baseline duration | Baseline 1 start | Baseline 1 finish | Total slack | Constraint | Baseline cost | Task Status | Update Version | Sched Status | MHHS Resource Name | RAG | Responsible | Involved | MHHS Programme Phase | Artefact ID | Milestone ID | Text29 | Tier | Text3 |
| --- | --- | --- | --- | --- | --- | --- | --- | --- | --- | --- | --- | --- | --- | --- | --- | --- | --- | --- | --- | --- | --- | --- | --- | --- | --- | --- | --- | --- | --- | --- |
| 1221 | 1.4.1.4.8.7 | **Azure DevOps Changes - Final Implementation** |  | 1d? | 2024-10-03 A | 2024-10-03 A |  | 100% |  | 2024-10-03 | 2024-10-03 |  |  |  |  |  |  | -701.67 | 6.1 | Overdue Start | Heath Thomas |  |  |  |  |  |  |  |  |  |
| 1222 | 1.4.1.4.8.7.1 | Final task rollout |  | 1d? | 2024-10-03 A | 2024-10-03 A |  | 100% |  | 2024-10-03 | 2024-10-03 |  |  |  |  | start no earlier than 2024-10-03 |  |  | 6.1 | Complete |  | COMPLETE |  |  |  |  |  |  |  |  |
| 1223 | 1.4.1.4.8.7.2 | ADO Training Drop-in Session ahead of Cycle 3 |  | 1d? | 2024-10-03 A | 2024-10-03 A |  | 100% |  | 2024-10-03 | 2024-10-03 |  |  |  |  | start no earlier than 2024-10-03 |  |  | 6.1 | Complete |  | COMPLETE |  |  |  |  |  |  |  |  |
| 1224 | 1.4.2 | **SIT Execution** |  | 804d? | 2022-10-31 A | 2025-11-27 |  | 15% | 682.06d? | 2022-10-31 | 2025-11-27 | 390d | 2023-10-30 | 2025-04-25 | 540d |  | -0 |  | 5.0 |  | N/A |  | N/A | N/A | Systems Integration Testing (SIT) |  |  |  |  |  |
| 1225 | 1.4.2.1 | System Integration Testing Start (M9) | milestone | 0d | 2023-10-30 A | 2023-10-30 A | 667FS+5d, 581 | 100% |  | 2023-10-30 | 2023-10-30 | 0d | 2023-10-30 | 2023-10-30 |  | must start on 2023-10-30 |  |  | 5.11 | Complete |  | COMPLETE | CPT | PMO | Systems Integration Testing (SIT) | MHHS-ART071 | T1-TE-1000 | PSG | T1 |  |
| 1226 | 1.4.2.2 | **SIT Component Integration Testing** |  | 96d | 2023-10-30 A | 2024-03-11 A |  | 100% |  | 2023-10-30 | 2024-03-11 | 95d | 2023-10-30 | 2024-03-08 |  |  |  |  | 5.0 |  | N/A |  | N/A | N/A | Systems Integration Testing (SIT) |  |  |  |  | D24A - Industry Integration Test Completion Report |
| 1227 | 1.4.2.2.1 | SIT Component Integration Testing Start | milestone | 0d | 2023-10-30 A | 2023-10-30 A | 1225 | 100% |  | 2023-10-30 | 2023-10-30 | 0d | 2023-10-30 | 2023-10-30 |  |  |  |  | 5.11 | Complete |  | COMPLETE | SI Test | PP | Systems Integration Testing (SIT) |  |  |  |  |  |
| 1228 | 1.4.2.2.2 | Component Integration Testing Interval 1 Start | milestone | 0d | 2023-10-30 A | 2023-10-30 A | 667SS+1d, 588, 592, 596, 114 | 100% |  | 2023-10-30 | 2023-10-30 | 0d | 2023-10-30 | 2023-10-30 |  |  |  |  | 5.11 | Complete |  | COMPLETE | SI Test | PP | Systems Integration Testing (SIT) | MHHS-ART071 | T3-TE-0060 | SITAG | T3 |  |
| 1229 | 1.4.2.2.3 | Component Integration Testing Interval 2 Start | milestone | 0d | 2023-11-13 A | 2023-11-13 A | 694SS+5d, 588, 596, 592, 114 | 100% |  | 2023-11-13 | 2023-11-13 | 0d | 2023-11-13 | 2023-11-13 |  |  |  |  | 5.12 | Complete |  | COMPLETE | SI Test | PP | Systems Integration Testing (SIT) |  | T3-TE-0061 | SITAG | T3 |  |
| 1230 | 1.4.2.2.4 | Component Integration Testing Interval 3 Start | milestone | 0d | 2023-11-27 A | 2023-11-27 A | 726SS+5d, 588, 592, 596, 114 | 100% |  | 2023-11-27 | 2023-11-27 | 0d | 2023-11-27 | 2023-11-27 |  |  |  |  | 5.0 | Complete |  | COMPLETE | SI Test | PP | Systems Integration Testing (SIT) |  | T3-TE-0062 | SITAG | T3 |  |
| 1231 | 1.4.2.2.5 | Component Integration Testing Interval 4 Start | milestone | 0d | 2023-12-11 A | 2023-12-11 A | 758SS+5d, 588, 592, 596, 114 | 100% |  | 2023-12-11 | 2023-12-11 | 0d | 2023-12-11 | 2023-12-11 |  |  |  |  | 5.0 | Complete |  | COMPLETE | SI Test | PP | Systems Integration Testing (SIT) |  | T3-TE-0063 | SITAG | T3 |  |
| 1232 | 1.4.2.2.6 | Component Integration Testing Interval 5 Start | milestone | 0d | 2024-01-15 A | 2024-01-15 A | 790SS+5d, 588, 592, 596, 114 | 100% |  | 2024-01-15 | 2024-01-15 | 0d | 2024-01-15 | 2024-01-15 |  |  |  |  | 5.0 | Complete |  | COMPLETE | SI Test | PP | Systems Integration Testing (SIT) |  | T3-TE-0064 |  | T3 |  |
| 1233 | 1.4.2.2.7 | Component Integration Testing Interval 6 Start | milestone | 0d | 2024-01-29 A | 2024-01-29 A | 588, 592, 596, 822, 114, 634 | 100% |  | 2024-01-29 | 2024-01-29 | 0d | 2024-01-29 | 2024-01-29 |  | must start on 2024-01-29 |  |  | 5.0 | Complete |  | COMPLETE | SI Test | PP | Systems Integration Testing (SIT) |  | T3-TE-0065 | SITAG | T3 |  |
| 1234 | 1.4.2.2.8 | SIT Component Integration Testing Execution |  | 85d | 2023-10-30 A | 2024-02-23 A | 1228SS | 100% |  | 2023-10-30 | 2024-02-23 | 85d | 2023-10-30 | 2024-02-23 |  | must start on 2023-10-30 |  |  | 5.0 | Complete |  | COMPLETE | SI Test | PP | Systems Integration Testing (SIT) |  |  |  |  | D24A - Industry Integration Test Completion Report |
| 1235 | 1.4.2.2.9 | SIT Component Integration Testing End (incl. confirmation that PPs have submitted their Test Completion Reports to Programme for assurance) | milestone | 0d | 2024-02-23 A | 2024-02-23 A | 1234FF | 100% |  | 2024-02-23 | 2024-02-23 | 0d | 2024-02-23 | 2024-02-23 |  |  |  |  | 5.19 | Complete |  | COMPLETE | SI Test | PP | Systems Integration Testing (SIT) | MHHS-ART074 | T3-TE-0032 | SITAG | T3 |  |
| 1236 | 1.4.2.2.10 | Assurance of PPs Test Completion Reports |  | 30d | 2024-01-22 A | 2024-03-01 A | 1235FF+5d | 100% |  | 2024-01-22 | 2024-03-01 | 30d | 2024-01-22 | 2024-03-01 |  |  |  |  | 5.19 | Complete |  | COMPLETE | SI Test | PP | Systems Integration Testing (SIT) |  |  |  |  |  |
| 1237 | 1.4.2.2.11 | **SIT CI Test Completion Report** |  | 18d | 2024-02-07 A | 2024-03-01 A |  | 100% |  | 2024-02-07 | 2024-03-01 | 18d | 2024-02-07 | 2024-03-01 |  |  |  |  | 5.0 |  | N/A |  | N/A | N/A | Systems Integration Testing (SIT) |  |  |  |  |  |
| 1238 | 1.4.2.2.11.1 | Develop document |  | 13d | 2024-02-07 A | 2024-02-23 A | 1235FF | 100% |  | 2024-02-07 | 2024-02-23 | 13d | 2024-02-07 | 2024-02-23 |  |  |  |  | 5.19 | Complete |  | COMPLETE | SI Test |  | Systems Integration Testing (SIT) |  |  |  |  |  |
| 1239 | 1.4.2.2.11.2 | Review & agree document |  | 5d | 2024-02-26 A | 2024-03-01 A | 1238, 1236FF | 100% |  | 2024-02-26 | 2024-03-01 | 5d | 2024-02-26 | 2024-03-01 |  |  |  |  | 5.19 | Complete |  | COMPLETE | SI Test | PP,IPA | Systems Integration Testing (SIT) |  |  |  |  |  |
| 1240 | 1.4.2.2.12 | SIT Component Integration Testing Test Completion Report Approved | milestone | 0d | 2024-03-11 A | 2024-03-11 A | 1239FS+6d | 100% |  | 2024-03-11 | 2024-03-11 | 0d | 2024-03-08 | 2024-03-08 |  |  |  |  | 5.18 | Complete |  | COMPLETE | SI Test | PP | Systems Integration Testing (SIT) | MHHS-ART074 | T2-TE-0600 | SITAG | T2 |  |
| 1241 | 1.4.2.3 | **SIT - Minimum Viable Cohort (MVC)** |  | 735d? | 2022-10-31 A | 2025-08-22 |  | 8% | 678.55d? | 2022-10-31 | 2025-08-22 | 240d | 2024-03-11 | 2025-02-07 | 609d |  | -0 |  | 5.0 |  | N/A |  | N/A | N/A | Systems Integration Testing (SIT) |  |  |  |  |  |
| 1242 | 1.4.2.3.1 | **SIT Functional Testing (MVC)** |  | 730d? | 2022-10-31 A | 2025-08-15 |  | 20% | 586.78d? | 2022-10-31 | 2025-08-15 | 225d | 2024-03-11 | 2025-01-17 | 614d |  |  |  | 5.0 |  | N/A |  | N/A | N/A | Systems Integration Testing (SIT) |  |  |  |  |  |
| 1243 | 1.4.2.3.1.1 | SIT Functional Testing Start | milestone | 0d | 2024-03-11 A | 2024-03-11 A | 1240, 952FS+5d, 829, 837, 838, 839, 846 | 100% |  | 2024-03-11 | 2024-03-11 | 0d | 2024-03-11 | 2024-03-11 |  |  |  |  | 6.1 | Complete |  | COMPLETE | SI Test | PP | Systems Integration Testing (SIT) | MHHS-ART073 | T3-TE-0034 | SITAG | T3 |  |
| 1244 | 1.4.2.3.1.2 | **SIT Functional Testing Execution (Minimum Viable Cohort)** |  | 730d? | 2022-10-31 A | 2025-08-15 |  | 20% | 586.78d? | 2022-10-31 | 2025-08-15 | 225d | 2024-03-11 | 2025-01-17 | 614d |  |  | M10 | 5.0 |  | N/A |  | N/A | N/A | Systems Integration Testing (SIT) |  |  |  |  | D24C - E2E Test Completion Report |
| 1245 | 1.4.2.3.1.2.1 | **Cycle 1 (Full Cycle)** |  | 70d | 2024-03-11 A | 2024-06-14 A |  | 100% |  | 2024-03-11 | 2024-06-14 | 90d | 2024-03-11 | 2024-07-12 |  |  |  |  | 5.0 |  | N/A |  | N/A | N/A | Systems Integration Testing (SIT) |  |  |  |  |  |
| 1246 | 1.4.2.3.1.2.1.1 | Test Execution |  | 55d | 2024-03-11 A | 2024-05-24 A | 1243SS-1d, 911 | 100% |  | 2024-03-11 | 2024-05-24 | 80d | 2024-03-11 | 2024-06-28 |  |  |  |  | 5.0 | Complete |  | COMPLETE | PP | SI Test | Systems Integration Testing (SIT) |  |  |  |  |  |
| 1247 | 1.4.2.3.1.2.1.2 | Defect resolution, assurance, review, data & environments maintenance |  | 15d | 2024-05-27 A | 2024-06-14 A | 1246 | 100% |  | 2024-05-27 | 2024-06-14 | 10d | 2024-07-01 | 2024-07-12 |  |  |  |  | 5.0 | Complete |  | COMPLETE | SI Test | PP | Systems Integration Testing (SIT) |  |  |  |  |  |

Notes:
- 1225: On track, however there are a number of associated risks that are being mitigated by the Programme
- 1228: On track, however there are a number of associated risks that are being mitigated by the Programme
- 1231: 13/12 - Complete noting a work-off plan and revised CIT Approach being taken to Dec TMAG
- 1232: 2/1//24 - Approved at 20/12 TMAG based on CIT Gov approach change
- 1233: 2/1//24 - Approved at 20/12 TMAG based on CIT Gov approach change
- 1235: All PPs are expected to complete their CIT by the target date on 09-Feb
- 1240: 20/2 - Date changed to align with SITAG meeting. On track for approval 11/3
- 1243: 28/11 - At risk because of challenges with CCP and PP readiness & dependent on successful Secondary Routing Testing

| ID | WBS | Task | Type | Duration | Start | Finish | Predecessors | Complete | Remaining | Baseline start | Baseline finish | Baseline duration | Baseline 1 start | Baseline 1 finish | Total slack | Free slack | Constraint | Responsible | Involved | Update Version | MHHS Resource Name | MHHS Programme Phase | Sched Status | RAG | Task Status | Milestone ID | Text29 | Tier |
| --- | --- | --- | --- | --- | --- | --- | --- | --- | --- | --- | --- | --- | --- | --- | --- | --- | --- | --- | --- | --- | --- | --- | --- | --- | --- | --- | --- | --- |
| 1248 | 1.4.2.3.1.2.2 | **Cycle 2 (Defect retests and targeted regression testing)** |  | 80d | 2024-06-17 A | 2024-10-04 |  | 41% | 47d | 2024-06-17 | 2024-10-04 | 50d | 2024-07-15 | 2024-09-20 | 839d |  |  | N/A | N/A | 5.0 | N/A | Systems Integration Testing (SIT) |  |  |  |  |  |  |
| 1249 | 1.4.2.3.1.2.2.1 | Test Execution |  | 70d | 2024-06-17 A | 2024-09-20 | 1247, 916 | 47% | 37d | 2024-06-17 | 2024-09-20 | 40d | 2024-07-15 | 2024-09-06 | 190d | 0d |  | PP | SI Test | 5.0 | Roger Robar | Systems Integration Testing (SIT) | Green | GREEN |  |  |  |  |
| 1250 | 1.4.2.3.1.2.2.2 | Defect resolution, assurance, review, data & environments maintenance |  | 10d | 2024-09-23 | 2024-10-04 | 1249 |  |  | 2024-09-23 | 2024-10-04 | 10d | 2024-09-09 | 2024-09-20 | 839d | 0d |  | SI Test | PP | 5.0 | Roger Robar | Systems Integration Testing (SIT) | Green | GREEN | -24.67 |  |  |  |
| 1251 | 1.4.2.3.1.2.3 | **SIT Functional Testing back-up progress risk-assessment** |  | 0d | 2022-10-31 | 2022-10-31 |  |  |  | 2022-10-31 | 2022-10-31 | 20d | 2024-09-23 | 2024-10-18 | 1344d |  |  | N/A | N/A | 5.31 | N/A | Systems Integration Testing (SIT) |  |  |  |  |  |  |
| 1252 | 1.4.2.3.1.2.3.1 | Back-up risk-assessment of SIT Functional progress to assess whether Qualification Execution can start early | inactive | 15d | 2024-10-07 | 2024-10-25 | 1250 |  |  | 2024-10-07 | 2024-10-25 | 15d | 2024-09-23 | 2024-10-11 | 819d | 0d |  | SI Test | Code Bodies,PP,IPA | 5.31 | Nicola Farley | Systems Integration Testing (SIT) |  | GREEN | -10.67 |  |  |  |
| 1253 | 1.4.2.3.1.2.3.2 | Back-up SITAG decision on early Qualification Testing Execution start | milestone, inactive | 0d | 2024-11-01 | 2024-11-01 | 1252FS+5d |  |  | 2024-11-01 | 2024-11-01 | 0d | 2024-10-18 | 2024-10-18 | 819d |  |  | SI Test | Code Bodies,PP,IPA | 5.31 | Nicola Farley | Systems Integration Testing (SIT) |  | GREEN | 14.71 | T3-TE-0041 | QAG | T3 |
| 1254 | 1.4.2.3.1.2.4 | **Cycle 3 (Defect retests and targeted regression testing)** |  | 105d? | 2024-10-21 | 2025-03-14 |  |  |  | 2024-10-21 | 2025-03-14 | 30d | 2024-09-23 | 2024-11-01 |  |  |  | N/A | N/A | 5.0 | N/A | Systems Integration Testing (SIT) |  |  |  |  |  |  |
| 1255 | 1.4.2.3.1.2.4.1 | Sprint 5 |  | 10d? | 2024-10-21 | 2024-11-01 | 140SS-1d |  |  | 2024-10-21 | 2024-11-01 | 0d |  |  | 5d | 0d |  |  |  | 6.0 | Roger Robar |  | Green | GREEN | 3.33 |  |  |  |
| 1256 | 1.4.2.3.1.2.4.2 | Sprint 6 |  | 10d? | 2024-11-04 | 2024-11-15 | 1255 |  |  | 2024-11-04 | 2024-11-15 | 0d |  |  | 5d | 0d |  |  |  | 6.0 | Roger Robar |  | Green | GREEN | 17.33 |  |  |  |
| 1257 | 1.4.2.3.1.2.4.3 | Sprint 7 |  | 10d? | 2024-11-18 | 2024-11-29 | 1256 |  |  | 2024-11-18 | 2024-11-29 | 0d |  |  | 5d | 0d |  |  |  | 6.0 | Roger Robar |  | Green | GREEN | 31.33 |  |  |  |
| 1258 | 1.4.2.3.1.2.4.4 | Sprint 8 |  | 15d? | 2024-12-02 | 2024-12-20 | 1257 |  |  | 2024-12-02 | 2024-12-20 | 0d |  |  | 5d | 0d |  |  |  | 6.0 | Roger Robar |  | Green | GREEN | 45.33 |  |  |  |
| 1259 | 1.4.2.3.1.2.4.5 | Christmas downtime |  | 10d? | 2024-12-23 | 2025-01-03 | 1258 |  |  | 2024-12-23 | 2025-01-03 | 0d |  |  | 5d | 0d |  |  |  | 6.0 | Roger Robar |  | Green | GREEN | 66.33 |  |  |  |
| 1260 | 1.4.2.3.1.2.4.6 | Sprint 9 |  | 10d? | 2025-01-06 | 2025-01-17 | 1259 |  |  | 2025-01-06 | 2025-01-17 | 0d |  |  | 5d | 0d |  |  |  | 6.0 | Roger Robar |  | Green | GREEN | 80.33 |  |  |  |
| 1261 | 1.4.2.3.1.2.4.7 | Sprint 10 |  | 10d? | 2025-01-20 | 2025-01-31 | 1260 |  |  | 2025-01-20 | 2025-01-31 | 0d |  |  | 5d | 0d |  |  |  | 6.0 | Roger Robar |  | Green | GREEN | 94.33 |  |  |  |
| 1262 | 1.4.2.3.1.2.4.8 | Sprint 11 |  | 10d? | 2025-02-03 | 2025-02-14 | 1261 |  |  | 2025-02-03 | 2025-02-14 | 0d |  |  | 5d | 0d |  |  |  | 6.0 | Roger Robar |  | Green | GREEN | 108.33 |  |  |  |
| 1263 | 1.4.2.3.1.2.4.9 | Sprint 12 |  | 10d? | 2025-02-17 | 2025-02-28 | 1262 |  |  | 2025-02-17 | 2025-02-28 | 0d |  |  | 5d | 0d |  |  |  | 6.0 | Roger Robar |  | Green | GREEN | 122.33 |  |  |  |
| 1264 | 1.4.2.3.1.2.4.10 | Sprint 13 (RTTM Gap Analysis + CR056) |  | 10d? | 2025-03-03 | 2025-03-14 | 1263 |  |  | 2025-03-03 | 2025-03-14 | 0d |  |  | 5d | 0d |  |  |  | 6.0 | Roger Robar |  | Green | GREEN | 136.33 |  |  |  |
| 1265 | 1.4.2.3.1.2.4.11 | Sprint 14 (RTTM Gap Analysis + CR056) |  | 10d? | 2025-03-17 | 2025-03-28 | 1264 |  |  | 2025-03-17 | 2025-03-28 |  |  |  | 5d | 0d |  |  |  | 6.1 |  |  | Green | GREEN | 150.33 |  |  |  |
| 1266 | 1.4.2.3.1.2.4.12 | Sprint 15 (Contingency 1) |  | 10d? | 2025-03-31 | 2025-04-11 | 1265 |  |  | 2025-03-31 | 2025-04-11 |  |  |  | 5d | 0d |  |  |  | 6.1 |  |  | Green | GREEN | 164.33 |  |  |  |
| 1267 | 1.4.2.3.1.2.4.13 | Sprint 16 (Contingency 2) |  | 10d? | 2025-04-14 | 2025-04-25 | 1266 |  |  | 2025-04-14 | 2025-04-25 |  |  |  | 5d | 0d |  |  |  | 6.1 |  |  | Green | GREEN | 178.33 |  |  |  |
| 1268 | 1.4.2.3.1.2.4.14 | Defect resolution, assurance, review, data & environments maintenance |  | 10d | 2024-10-21 | 2024-11-01 |  |  |  | 2024-10-21 | 2024-11-01 | 10d | 2024-10-21 | 2024-11-01 | 819d |  |  | SI Test | PP | 5.0 | Roger Robar | Systems Integration Testing (SIT) | Green | GREEN | 3.33 |  |  |  |
| 1269 | 1.4.2.3.1.2.5 | **SIT Functional Settlement Testing** |  | 230d? | 2024-06-17 | 2025-05-02 |  |  |  | 2024-06-17 | 2025-05-02 | 0d |  |  |  |  |  |  |  | 6.0 |  |  | Overdue Start | RED | -685.67 |  |  |  |
| 1270 | 1.4.2.3.1.2.5.1 | Settlement Testing Cycle 1 |  | 70d | 2024-06-17 | 2024-09-20 |  |  |  | 2024-06-17 | 2024-09-20 | 0d |  |  | 849d |  | start no earlier than 2024-06-17 |  |  | 6.0 |  |  | Overdue Start | GREEN | -122.67 |  |  |  |
| 1271 | 1.4.2.3.1.2.5.2 | Settlement Testing Cycle 2 |  | 55d? | 2024-10-07 | 2024-12-20 | 1144 |  |  | 2024-10-07 | 2024-12-20 | 0d |  |  | 38d | 0d |  |  |  | 6.0 |  |  | Green | GREEN | -10.67 |  |  |  |
| 1272 | 1.4.2.3.1.2.5.3 | Settlement Testing Cycle 3 (CoS Settlement Testing) |  | 20d? | 2025-05-19 | 2025-06-13 | 942, 1171 |  |  | 2025-05-19 | 2025-06-13 | 0d |  |  | 5d | 0d |  |  |  | 6.0 |  |  | Green | GREEN | 213.33 |  |  |  |

Notes:
- 1252: Action: 5/12 - LC said change name from his to nicola and check dates based on new start date for non sit ldso testing
- 1253: 15/8/24: Milestone to be removed as no longer applicable / Guidance: 13/8/24: To be removed because SIT has not made sufficient progress to allow early quaifation test start. 22/8/24: Approved at QAG on 22/8/24 to be removed

| ID | WBS | Task | Type | Duration | Start | Finish | Predecessors | Baseline start | Baseline finish | Baseline duration | Baseline 1 start | Baseline 1 finish | Total slack | Free slack | Constraint | Baseline cost | Responsible | Involved | Task Status | Update Version | Sched Status | MHHS Programme Phase | RAG | MHHS Resource Name | Artefact ID | Milestone ID | Text29 | Tier |
| --- | --- | --- | --- | --- | --- | --- | --- | --- | --- | --- | --- | --- | --- | --- | --- | --- | --- | --- | --- | --- | --- | --- | --- | --- | --- | --- | --- | --- |
| 1273 | 1.4.2.3.1.2.6 | **SIT Functional MVC Regression Testing (code freeze)** |  | 40d? | 2025-06-16 | 2025-08-08 |  | 2025-06-16 | 2025-08-08 | 45d | 2024-11-04 | 2025-01-03 | 5d |  |  |  | PP | SI Test | 84.33 | 5.0 | Red | Systems Integration Testing (SIT) | RED |  |  |  |  |  |
| 1274 | 1.4.2.3.1.2.6.1 | Regression Sprint 1 |  | 10d? | 2025-06-16 | 2025-06-27 | 1272, 1167 | 2025-06-16 | 2025-06-27 | 0d |  |  | 5d | 0d |  |  |  |  | 241.33 | 6.0 | Green |  | GREEN | Roger Robar |  |  |  |  |
| 1275 | 1.4.2.3.1.2.6.2 | Regression Sprint 2 |  | 10d | 2025-06-30 | 2025-07-11 | 1274 | 2025-06-30 | 2025-07-11 | 0d |  |  | 5d | 0d |  |  |  |  | 255.33 | 6.0 | Green |  | GREEN | Roger Robar |  |  |  |  |
| 1276 | 1.4.2.3.1.2.6.3 | Regression Sprint 3 |  | 15d | 2025-07-14 | 2025-08-01 | 1275 | 2025-07-14 | 2025-08-01 | 0d |  |  | 5d | 0d |  |  |  |  | 269.33 | 6.0 | Green |  | GREEN | Roger Robar |  |  |  |  |
| 1277 | 1.4.2.3.1.2.6.4 | SIT Functional Testing End (Minimum Viable Cohort) (incl. confirmation that PPs have submitted their Test Completion Reports to Programme for assurance) | milestone | 0d | 2025-08-01 | 2025-08-01 | 1276 | 2025-08-01 | 2025-08-01 | 0d | 2025-01-03 | 2025-01-03 | 5d | 0d | start no earlier than 2025-03-14 |  | SI Test | PP | 287.71 | 6.1 | Green | Systems Integration Testing (SIT) | AMBER | Roger Robar | MHHS-ART072 | T3-TE-0046 | SITAG | T3 |
| 1278 | 1.4.2.3.1.2.6.5 | Assurance of PPs Test Completion Reports |  | 30d | 2025-06-30 | 2025-08-08 | 1277FF+5d | 2025-06-30 | 2025-08-08 | 30d | 2024-12-02 | 2025-01-10 | 5d | 0d |  |  | SI Test | PP | 255.33 | 6.1 | Green | Systems Integration Testing (SIT) | GREEN | Roger Robar |  |  |  |  |
| 1279 | 1.4.2.3.1.2.7 | **SIT Functional Test Completion Report (Minimum Viable Cohort)** |  | 25d | 2025-07-14 | 2025-08-15 |  | 2025-07-14 | 2025-08-15 | 20d | 2024-12-16 | 2025-01-10 | 5d |  |  |  | N/A | N/A |  | 6.1 |  | Systems Integration Testing (SIT) |  | N/A |  |  |  |  |
| 1280 | 1.4.2.3.1.2.7.1 | Develop document |  | 15d | 2025-07-14 | 2025-08-01 | 1277FF | 2025-07-14 | 2025-08-01 | 15d | 2024-12-16 | 2025-01-03 | 5d | 0d |  |  | SI Test |  | 269.33 | 6.1 | Green | Systems Integration Testing (SIT) | GREEN | Roger Robar |  |  |  |  |
| 1281 | 1.4.2.3.1.2.7.2 | Review & agree document |  | 5d | 2025-08-04 | 2025-08-08 | 1280, 1278FF | 2025-08-04 | 2025-08-08 | 5d | 2025-01-06 | 2025-01-10 | 5d | 0d |  |  | SI Test | PP,IPA | 290.33 | 6.1 | Green | Systems Integration Testing (SIT) | GREEN | Roger Robar |  |  |  |  |
| 1282 | 1.4.2.3.1.2.7.3 | SIT Functional Testing Test Completion Report (Minimum Viable Cohort) Approved | milestone | 0d | 2025-08-15 | 2025-08-15 | 1281FF+5d | 2025-08-15 | 2025-08-15 | 0d | 2025-01-17 | 2025-01-17 | 5d | 0d |  |  | SI Test | PP | 301.71 | 6.1 | Green | Systems Integration Testing (SIT) | AMBER | Roger Robar | MHHS-ART072 | T2-TE-0850 | SITAG | T2 |
| 1283 | 1.4.2.3.2 | **Helix E2E Settlement Testing** |  | 65d | 2025-01-06 | 2025-04-04 |  | 2025-01-06 | 2025-04-04 |  |  |  | 38d |  |  |  |  |  | -689.67 |  | Overdue Start |  | RED | Helix |  |  |  |  |
| 1284 | 1.4.2.3.2.1 | Helix E2E Settlement Testing Execution |  | 65d | 2025-01-06 | 2025-04-04 | 1271FS+10d | 2025-01-06 | 2025-04-04 |  |  |  | 38d | 0d |  |  |  |  | 80.33 | 6.0 | Green |  | GREEN | Helix |  |  |  |  |
| 1285 | 1.4.2.3.2.2 | Helix E2E Settlement Testing Execution Complete | milestone | 0d | 2025-04-04 | 2025-04-04 | 1284 | 2025-04-04 | 2025-04-04 |  |  |  | 38d | 0d |  |  |  |  | 168.71 | 6.0 | Green |  | GREEN | Helix |  |  |  |  |
| 1286 | 1.4.2.3.2.3 | MHHSP Helix E2E Testing Assurance |  | 65d | 2025-01-06 | 2025-04-04 | 1271FS+10d | 2025-01-06 | 2025-04-04 |  |  |  | 38d | 0d |  |  |  |  | 80.33 | 6.0 | Green |  | GREEN | Helix |  |  |  |  |
| 1287 | 1.4.2.3.2.4 | MHHSP Helix E2E Testing Assurance Complete | milestone | 0d | 2025-04-04 | 2025-04-04 | 1286 | 2025-04-04 | 2025-04-04 |  |  |  | 38d | 0d |  |  |  |  | 168.71 | 6.0 | Green |  | GREEN | Helix |  |  |  |  |
| 1288 | 1.4.2.3.3 | **SIT Migration Testing (MVC)** |  | 380d? | 2024-03-11 | 2025-08-22 |  | 2024-03-11 | 2025-08-22 | 155d | 2024-06-10 | 2024-10-18 | 0d |  |  | -0 | N/A | N/A |  | 5.0 | Overdue | Systems Integration Testing (SIT) | GREEN | N/A |  |  |  |  |
| 1289 | 1.4.2.3.3.1 | SIT Migration Testing Start | milestone | 0d? | 2024-03-11 | 2024-03-11 |  | 2024-03-11 | 2024-03-11 | 0d |  |  | 989d |  | start no earlier than 2024-03-11 |  |  |  | -220.67 | 6.0 | Overdue Start |  | RED |  |  |  |  |  |
| 1290 | 1.4.2.3.3.2 | **SIT Migration Testing Execution (Minimum Viable Cohort)** |  | 380d? | 2024-03-11 | 2025-08-22 |  | 2024-03-11 | 2025-08-22 | 0d |  |  | 0d |  |  |  |  |  | -685.67 | 6.0 | Overdue Start |  | RED |  |  |  |  |  |
| 1291 | 1.4.2.3.3.2.1 | **Cycle 1 (Full Cycle)** |  | 70d? | 2024-03-11 | 2024-06-14 |  | 2024-03-11 | 2024-06-14 | 0d |  |  |  |  |  |  |  |  | -685.67 | 6.0 | Overdue Start |  | RED |  |  |  |  |  |
| 1292 | 1.4.2.3.3.2.1.1 | Test Execution |  | 55d? | 2024-03-11 | 2024-05-24 |  |  |  |  |  |  | 934d |  | start no earlier than 2024-03-11 |  |  |  | -220.67 | 6.0 | Overdue Start |  | RED |  |  |  |  |  |
| 1293 | 1.4.2.3.3.2.1.2 | Defect resolution, assurance, review, data& environments maintenance |  | 15d? | 2024-05-27 | 2024-06-14 |  |  |  |  |  |  | 819d | 0d | finish no earlier than 2024-06-14 |  |  |  | -143.67 | 6.0 | Overdue Start |  | RED |  |  |  |  |  |
| 1294 | 1.4.2.3.3.2.2 | **Cycle 2 (Defect retests and targeted regression testing)** |  | 80d? | 2024-03-11 | 2024-06-28 |  | 2024-03-11 | 2024-06-28 | 0d |  |  |  |  |  |  |  |  | -685.67 | 6.0 | Overdue Start |  | RED |  |  |  |  |  |
| 1295 | 1.4.2.3.3.2.2.1 | Test Execution |  | 70d? | 2024-06-17 | 2024-09-20 | 1293 |  |  |  |  |  | 819d | 0d | start no earlier than 2024-06-17 |  |  |  | -122.67 | 6.0 | Overdue Start |  | GREEN |  |  |  |  |  |
| 1296 | 1.4.2.3.3.2.2.2 | Defect resolution, assurance, review, data & environments maintenance |  | 10d? | 2024-09-23 | 2024-10-04 | 1295 |  |  |  |  |  | 819d | 0d | finish no earlier than 2024-10-04 |  |  |  | -24.67 | 6.0 | No BL |  | GREEN |  |  |  |  |  |

Notes:
- 1277: 16/09/24 - Date pushed back to 14/03/25, in line with recalibration exercise.
- 1282: 6/8/24: Date at risk due to lower than expected test velocity. Completion of Functional could be delayed. Programme-wide scenario re-planning underway

| ID | WBS | Task | Type | Duration | Start | Finish | Predecessors | Baseline start | Baseline finish | Baseline duration | Baseline 1 start | Baseline 1 finish | Total slack | Free slack | Constraint | Task Status | Update Version | Sched Status | RAG | MHHS Resource Name | Responsible | Involved | Artefact ID | MHHS Programme Phase | Milestone ID | Text29 | Tier | Text3 |
| --- | --- | --- | --- | --- | --- | --- | --- | --- | --- | --- | --- | --- | --- | --- | --- | --- | --- | --- | --- | --- | --- | --- | --- | --- | --- | --- | --- | --- |
| 1297 | 1.4.2.3.3.2.3 | **SIT Functional Testing back-up progress risk-assessment** |  | 70d? | 2024-06-17 | 2024-09-20 |  | 2024-06-17 | 2024-09-20 | 0d |  |  |  |  |  | -685.67 | 6.0 | Overdue Start | RED |  |  |  |  |  |  |  |  |  |
| 1298 | 1.4.2.3.3.2.3.1 | Back-up risk-assessment of SIT Migration progress to assess whether Qualification Execution can start early |  | 15d? | 2024-10-07 | 2024-10-25 | 1296 | 2024-10-07 | 2024-10-25 | 0d |  |  | 819d | 0d | finish no earlier than 2024-10-04 | -10.67 | 6.0 | Green | GREEN |  |  |  |  |  |  |  |  |  |
| 1299 | 1.4.2.3.3.2.3.2 | Back-up SITAG decision on early Qualification Testing Execution start | milestone | 0d? | 2024-11-01 | 2024-11-01 | 1298FS+5d | 2024-11-01 | 2024-11-01 | 0d |  |  | 819d |  |  | 14.71 | 6.0 | Green | GREEN |  |  |  |  |  |  |  |  |  |
| 1300 | 1.4.2.3.3.2.4 | **Cycle 3 (Defect retests and targeted regression testing)** |  | 135d? | 2024-10-21 | 2025-04-25 |  | 2024-10-21 | 2025-04-25 | 0d |  |  | 5d |  |  | -685.67 | 6.0 | Overdue Start | RED | Roger Robar |  |  |  |  |  |  |  |  |
| 1301 | 1.4.2.3.3.2.4.1 | Sprint 5 |  | 10d | 2024-10-21 | 2024-11-01 | 140FS-1d | 2024-10-21 | 2024-11-01 | 0d |  |  | 5d | 0d | start no earlier than 2024-10-21 | 3.33 | 6.0 | Green | GREEN |  |  |  |  |  |  |  |  |  |
| 1302 | 1.4.2.3.3.2.4.2 | Sprint 6 |  | 10d | 2024-11-04 | 2024-11-15 | 1301 | 2024-11-04 | 2024-11-15 | 0d |  |  | 5d | 0d | start no earlier than 2024-11-04 | 17.33 | 6.0 | Green | GREEN |  |  |  |  |  |  |  |  |  |
| 1303 | 1.4.2.3.3.2.4.3 | Sprint 7 |  | 10d | 2024-11-18 | 2024-11-29 | 1302 | 2024-11-18 | 2024-11-29 | 0d |  |  | 5d | 0d |  | 31.33 | 6.0 | Green | GREEN |  |  |  |  |  |  |  |  |  |
| 1304 | 1.4.2.3.3.2.4.4 | Sprint 8 |  | 15d | 2024-12-02 | 2024-12-20 | 1303 | 2024-12-02 | 2024-12-20 | 0d |  |  | 5d | 0d | finish no earlier than 2024-11-15 | 45.33 | 6.0 | Green | GREEN |  |  |  |  |  |  |  |  |  |
| 1305 | 1.4.2.3.3.2.4.5 | Christmas downtime |  | 10d | 2024-12-23 | 2025-01-03 | 1304 | 2024-12-23 | 2025-01-03 | 0d |  |  | 5d | 0d | finish no earlier than 2024-11-29 | 66.33 | 6.0 | Green | GREEN |  |  |  |  |  |  |  |  |  |
| 1306 | 1.4.2.3.3.2.4.6 | Sprint 9 |  | 10d | 2025-01-06 | 2025-01-17 | 1305 | 2025-01-06 | 2025-01-17 | 0d |  |  | 5d | 0d | finish no earlier than 2024-12-20 | 80.33 | 6.0 | Green | GREEN |  |  |  |  |  |  |  |  |  |
| 1307 | 1.4.2.3.3.2.4.7 | Sprint 10 |  | 10d | 2025-01-20 | 2025-01-31 | 1306 | 2025-01-20 | 2025-01-31 | 0d |  |  | 5d | 0d | finish no earlier than 2025-01-03 | 94.33 | 6.0 | Green | GREEN |  |  |  |  |  |  |  |  |  |
| 1308 | 1.4.2.3.3.2.4.8 | Sprint 11 |  | 10d | 2025-02-03 | 2025-02-14 | 1307 | 2025-02-03 | 2025-02-14 | 0d |  |  | 5d | 0d | finish no earlier than 2025-01-17 | 108.33 | 6.0 | Green | GREEN |  |  |  |  |  |  |  |  |  |
| 1309 | 1.4.2.3.3.2.4.9 | Sprint 12 |  | 10d | 2025-02-17 | 2025-02-28 | 1308 | 2025-02-17 | 2025-02-28 | 0d |  |  | 5d | 0d | finish no earlier than 2025-01-31 | 122.33 | 6.0 | Green | GREEN |  |  |  |  |  |  |  |  |  |
| 1310 | 1.4.2.3.3.2.4.10 | Sprint 13 |  | 10d | 2025-03-03 | 2025-03-14 | 1309 | 2025-03-03 | 2025-03-14 |  |  |  | 5d | 0d |  | 136.33 | 6.1 | Green | GREEN |  |  |  |  |  |  |  |  |  |
| 1311 | 1.4.2.3.3.2.4.11 | Sprint 14 (RTTM Gap Analysis + CR056) |  | 10d? | 2025-03-17 | 2025-03-28 | 1310 | 2025-03-17 | 2025-03-28 |  |  |  | 5d | 0d |  | 150.33 | 6.1 | Green | GREEN |  |  |  |  |  |  |  |  |  |
| 1312 | 1.4.2.3.3.2.4.12 | Sprint 15 (Contingency 1) |  | 10d? | 2025-03-31 | 2025-04-11 | 1311 | 2025-03-31 | 2025-04-11 |  |  |  | 5d | 0d |  | 164.33 | 6.1 | Green | GREEN |  |  |  |  |  |  |  |  |  |
| 1313 | 1.4.2.3.3.2.4.13 | Sprint 16 (Contingency 2) |  | 10d? | 2025-04-14 | 2025-04-25 | 1312 | 2025-04-14 | 2025-04-25 |  |  |  | 5d | 0d |  | 178.33 | 6.1 | Green | GREEN |  |  |  |  |  |  |  |  |  |
| 1314 | 1.4.2.3.3.2.5 | **SIT Migration MVC Regression Testing (code freeze)** |  | 35d? | 2025-06-16 | 2025-08-01 |  | 2025-06-16 | 2025-08-01 | 0d |  |  | 609d |  |  | -685.67 | 6.0 | Overdue Start | RED | Roger Robar |  |  |  |  |  |  |  |  |
| 1315 | 1.4.2.3.3.2.5.1 | Regression Sprint 1 |  | 10d? | 2025-06-16 | 2025-06-27 | 1272 | 2025-06-16 | 2025-06-27 | 0d |  |  | 609d | 0d |  | 241.33 | 6.0 | Green | GREEN |  |  |  |  |  |  |  |  |  |
| 1316 | 1.4.2.3.3.2.5.2 | Regression Sprint 2 |  | 10d? | 2025-06-30 | 2025-07-11 | 1315 | 2025-06-30 | 2025-07-11 | 0d |  |  | 609d | 0d |  | 255.33 | 6.0 | Green | GREEN |  |  |  |  |  |  |  |  |  |
| 1317 | 1.4.2.3.3.2.5.3 | Regression Sprint 3 |  | 15d? | 2025-07-14 | 2025-08-01 | 1316 | 2025-07-14 | 2025-08-01 | 0d |  |  | 609d | 0d |  | 269.33 | 6.0 | Green | GREEN |  |  |  |  |  |  |  |  |  |
| 1318 | 1.4.2.3.3.2.5.4 | SIT Migration Testing End (Minimum Viable Cohort) (incl. confirmation that PPs have submitted their Test Completion Reports to Programme for assurance) | milestone | 0d | 2025-08-01 | 2025-08-01 | 1317 | 2025-08-01 | 2025-08-01 | 0d |  |  | 609d | 0d | start no earlier than 2025-06-20 | 287.71 | 6.0 | Green | GREEN |  |  |  |  |  |  |  |  |  |
| 1319 | 1.4.2.3.3.2.6 | **SIT Migration Test Completion Report (Minimum Viable Cohort)** |  | 25d | 2025-07-14 | 2025-08-15 | 1013, 959, 963, 970, 976, 982 | 2025-07-14 | 2025-08-15 | 0d | 2024-06-10 | 2024-06-10 | 609d |  |  |  | 6.1 | Complete | COMPLETE |  | SI Test | PP | MHHS-ART076 | Systems Integration Testing (SIT) | T3-TE-0038 | SITAG | T3 |  |
| 1320 | 1.4.2.3.3.2.6.1 | Develop document |  | 15d | 2025-07-14 | 2025-08-01 | 1318FF | 2025-07-14 | 2025-08-01 | 85d | 2024-06-10 | 2024-10-04 | 609d | 0d |  | 269.33 | 6.1 | Green | GREEN | Roger Robar | SI Test | PP |  | Systems Integration Testing (SIT) |  |  |  | D24E - Migration Test Completion Report |
| 1321 | 1.4.2.3.3.2.6.2 | Review & agree document |  | 5d | 2025-08-04 | 2025-08-08 | 1320 | 2025-08-04 | 2025-08-08 | 10d | 2024-10-21 | 2024-11-01 | 609d | 0d |  | 290.33 | 6.1 | Green | GREEN | Roger Robar | SI Test | PP |  | Systems Integration Testing (SIT) |  |  |  |  |
| 1322 | 1.4.2.3.3.2.6.3 | SIT Migration Testing Test Completion Report (Minimum Viable Cohort) Approved | milestone | 0d | 2025-08-15 | 2025-08-15 | 1321FS+5d | 2025-08-15 | 2025-08-15 | 45d |  |  | 609d | 0d |  | 301.71 | 6.1 | Green | GREEN |  |  |  |  |  | T2-TE-0800 |  |  |  |
| 1323 | 1.4.2.3.3.2.7 | SIT Migration Testing End (Minimum Viable Cohort) (incl. confirmation that PPs have submitted their Test Completion Reports to Programme for assurance) | milestone | 0d | 2025-08-15 | 2025-08-15 | 1320FF, 1322 | 2025-08-15 | 2025-08-15 | 0d | 2024-10-04 | 2024-10-04 | 609d | 0d | start no earlier than 2025-03-14 | 301.71 | 6.1 | Green | AMBER | Roger Robar | SI Test | PP | MHHS-ART076 | Systems Integration Testing (SIT) | T3-TE-0043 | SITAG | T3 |  |
| 1324 | 1.4.2.3.3.2.8 | Assurance of PPs Test Completion Reports |  | 30d | 2025-07-14 | 2025-08-22 | 1323FF+5d | 2025-07-14 | 2025-08-22 | 30d | 2024-09-02 | 2024-10-11 | 609d |  |  | 269.33 | 6.1 | Green | GREEN | Roger Robar | SI Test | PP |  | Systems Integration Testing (SIT) |  |  |  |  |

Notes:
- 1319: 21/5: at risk because dependant on prioritised SIT F CoA tests. Subject to approval at eSITAG on 10/6. 11/6: Missed date because MPRS data and code not ready. Decision deferred to 17/6
- 1323: 16/09/24 - Date pushed back to 14/03/25, in line with recalibration exercise.

| ID | WBS | Task | Type | Duration | Start | Finish | Predecessors | Baseline start | Baseline finish | Baseline duration | Baseline 1 start | Baseline 1 finish | Total slack | Free slack | Constraint | Responsible | Involved | Update Version | MHHS Resource Name | MHHS Programme Phase | Task Status | Sched Status | RAG | Milestone ID | Artefact ID | Guidance | Text29 | Tier | Text3 |
| --- | --- | --- | --- | --- | --- | --- | --- | --- | --- | --- | --- | --- | --- | --- | --- | --- | --- | --- | --- | --- | --- | --- | --- | --- | --- | --- | --- | --- | --- |
| 1325 | 1.4.2.3.4 | **SIT Non-Functional Testing (all SIT PPs)** |  | 104d? | 2025-01-13 | 2025-06-05 |  | 2025-01-13 | 2025-06-05 | 100d | 2024-09-02 | 2025-01-17 | 60d |  |  | N/A | N/A | 5.0 | N/A | Systems Integration Testing (SIT) |  |  |  |  |  |  |  |  |  |
| 1326 | 1.4.2.3.4.1 | Theme 1 (Helix and DIP Volume Testing) Start | milestone | 0d? | 2025-01-13 | 2025-01-13 | 1066 | 2025-01-13 | 2025-01-13 |  |  |  | 60d | 0d | start no earlier than 2025-01-13 |  |  | 6.0 |  |  | 87.33 | Green | GREEN | T3-TE-0040 |  |  |  |  |  |
| 1327 | 1.4.2.3.4.2 | Theme 1 (Helix and DIP Volume Testing) Execution |  | 15d? | 2025-01-13 | 2025-01-31 | 1326 | 2025-01-13 | 2025-01-31 |  |  |  | 60d | 0d | start no earlier than 2025-01-13 |  |  | 6.0 |  |  | 87.33 | Green | GREEN |  |  |  |  |  |  |
| 1328 | 1.4.2.3.4.3 | Theme 2 SIT Non-Functional Testing Start | milestone | 0d | 2025-03-14 | 2025-03-14 | 1082FS+5d, 1249FS+5d, 1020, 1024, 1031, 1037, 1043, 1068, 1072 | 2025-03-14 | 2025-03-14 | 0d | 2024-09-02 | 2024-09-02 | 70d | 0d |  | SI Test | PP | 5.0 | Roger Robar | Systems Integration Testing (SIT) | 147.71 | Green | GREEN | T3-TE-0040 | MHHS-ART079 | 12/8/24: needs to be 7/10/24 | SITAG | T3 |  |
| 1329 | 1.4.2.3.4.4 | Theme 2 SIT Non-Functional Testing Execution |  | 40d | 2025-03-17 | 2025-05-09 | 1328SS | 2025-03-17 | 2025-05-09 | 90d | 2024-09-02 | 2025-01-03 | 70d | 9d |  | SI Test | PP | 5.0 | Roger Robar | Systems Integration Testing (SIT) | 150.33 | Green | GREEN |  |  |  |  |  | D24D - NF Test Completion Report |
| 1330 | 1.4.2.3.4.5 | Theme 3 SIT Non-Functional Testing Start |  | 1d? | 2025-03-17 | 2025-03-17 | 1068, 1072 | 2025-03-17 | 2025-03-17 |  |  |  | 70d | 0d |  |  |  | 5.0 |  |  | 150.33 | Green | GREEN |  |  |  |  |  |  |
| 1331 | 1.4.2.3.4.6 | Theme 3 SIT Non-Functional Testing Execution |  | 40d? | 2025-03-17 | 2025-05-09 | 1330SS | 2025-03-17 | 2025-05-09 |  |  |  | 70d | 9d |  |  |  | 5.0 |  |  | 150.33 | Green | GREEN |  |  |  |  |  |  |
| 1332 | 1.4.2.3.4.7 | SIT Non-Functional Testing End (all SIT PPs) (incl. confirmation that PPs have submitted their Test Completion Reports to Programme for assurance) | milestone | 0d | 2025-05-23 | 2025-05-23 | 1329FF, 1331FF | 2025-05-23 | 2025-05-23 | 0d | 2025-01-03 | 2025-01-03 | 61d | 0d | start no earlier than 2025-05-23 | SI Test | PP | 5.0 | Roger Robar | Systems Integration Testing (SIT) | 217.33 | Green | AMBER | T3-TE-0047 | MHHS-ART079 |  | SITAG | T3 |  |
| 1333 | 1.4.2.3.4.8 | Assurance of PPs Test Completion Reports |  | 20d | 2025-05-02 | 2025-05-29 | 1332FF+5d | 2025-05-02 | 2025-05-29 | 30d | 2024-12-02 | 2025-01-10 | 61d | 0d |  | SI Test | PP | 5.0 | Roger Robar | Systems Integration Testing (SIT) | 196.33 | Green | GREEN |  |  |  |  |  |  |
| 1334 | 1.4.2.3.4.9 | **SIT Non-Functional Testing Test Completion Report (all SIT PPs)** |  | 20d | 2025-05-02 | 2025-05-29 |  | 2025-05-02 | 2025-05-29 | 20d | 2024-12-16 | 2025-01-10 | 61d |  |  | N/A | N/A | 5.0 | N/A | Systems Integration Testing (SIT) |  |  |  |  |  |  |  |  |  |
| 1335 | 1.4.2.3.4.9.1 | Develop document |  | 15d | 2025-05-02 | 2025-05-23 | 1332FF | 2025-05-02 | 2025-05-23 | 15d | 2024-12-16 | 2025-01-03 | 61d | 0d |  | SI Test |  | 5.0 | Roger Robar | Systems Integration Testing (SIT) | 196.33 | Green | GREEN |  |  |  |  |  |  |
| 1336 | 1.4.2.3.4.9.2 | Review & agree document |  | 5d | 2025-05-23 | 2025-05-29 | 1335, 1333FF | 2025-05-23 | 2025-05-29 | 5d | 2025-01-06 | 2025-01-10 | 61d | 0d |  | SI Test | PP,IPA | 5.0 | Roger Robar | Systems Integration Testing (SIT) | 217.33 | Green | GREEN |  |  |  |  |  |  |
| 1337 | 1.4.2.3.4.10 | SIT Non-Functional Testing Test Completion Report (all SIT PPs) Approved | milestone | 0d | 2025-06-05 | 2025-06-05 | 1336FF+5d | 2025-06-05 | 2025-06-05 | 0d | 2025-01-17 | 2025-01-17 | 61d | 56d |  | SI Test | PP | 5.0 | Roger Robar | Systems Integration Testing (SIT) | 230.71 | Green | AMBER | T2-TE-0900 | MHHS-ART079 |  | SITAG | T2 |  |
| 1338 | 1.4.2.3.5 | **SIT Operational Testing (all SIT PPs)** |  | 90d? | 2025-02-03 | 2025-06-06 |  | 2025-02-03 | 2025-06-06 | 90d | 2024-10-07 | 2025-02-07 | 60d |  |  | N/A | N/A | 5.0 | N/A | Systems Integration Testing (SIT) |  |  |  |  |  |  |  |  |  |
| 1339 | 1.4.2.3.5.1 | **Non-SIT B Testing** |  | 25d? | 2025-02-03 | 2025-03-07 |  | 2025-02-03 | 2025-03-07 |  |  |  | 115d |  |  |  |  |  |  |  | -686.67 | Overdue Start | RED |  |  |  |  |  |  |
| 1340 | 1.4.2.3.5.1.1 | SIT Operational Testing Start (Theme 3 - Batch 1 (Service Management)) | milestone | 0d? | 2025-02-03 | 2025-02-03 | 1131, 1108, 1109, 1110, 1111, 1130 | 2025-02-03 | 2025-02-03 |  |  |  | 115d | 0d | start no earlier than 2025-02-03 |  |  | 6.0 |  |  | 108.33 | Green | GREEN | T3-TE-0121 |  |  |  |  |  |
| 1341 | 1.4.2.3.5.1.2 | SIT Operational Testing Execution Window (Theme 3 - Batch 1 (Service Management)) |  | 25d? | 2025-02-03 | 2025-03-07 | 1340 | 2025-02-03 | 2025-03-07 |  |  |  | 115d | 55d | start no earlier than 2025-01-06 |  |  | 6.0 |  |  | 108.33 | Green | GREEN |  |  |  |  |  |  |
| 1342 | 1.4.2.3.5.2 | **SIT B Testing** |  | 70d? | 2025-02-07 | 2025-05-16 |  | 2025-02-07 | 2025-05-16 |  |  |  | 60d |  |  |  |  | 5.0 |  |  | -686.67 | Overdue Start | RED |  |  |  |  |  |  |
| 1343 | 1.4.2.3.5.2.1 | SIT Operational Testing Start (SIT B) | milestone | 0d | 2025-02-07 | 2025-02-07 | 1152FS+8d, 1089, 1093, 1100, 1106, 1131, 1069, 1070 | 2025-02-07 | 2025-02-07 | 0d | 2024-10-07 | 2024-10-07 | 60d | 0d |  | SI Test | PP | 5.0 | Roger Robar | Systems Integration Testing (SIT) | 112.71 | Green | AMBER | T3-TE-0042 | MHHS-ART073 MHHS-ART143 |  | SITAG | T3 |  |
| 1344 | 1.4.2.3.5.2.2 | SIT Operational Testing Execution Theme 3 Batch 2 |  | 25d? | 2025-02-10 | 2025-03-14 | 1343, 1120 | 2025-02-10 | 2025-03-14 |  |  |  | 60d | 0d |  |  |  | 6.0 |  |  | 115.33 | Green | GREEN |  |  |  |  |  |  |
| 1345 | 1.4.2.3.5.2.3 | SIT Operational Testing Execution Theme 1 |  | 25d? | 2025-03-17 | 2025-04-18 | 1344 | 2025-03-17 | 2025-04-18 |  |  |  | 60d | 0d |  |  |  | 6.0 |  |  | 150.33 | Green | GREEN |  |  |  |  |  |  |
| 1346 | 1.4.2.3.5.2.4 | SIT Operational Testing Execution Theme 2 |  | 20d? | 2025-04-21 | 2025-05-16 | 1345 | 2025-04-21 | 2025-05-16 |  |  |  | 60d | 0d |  |  |  | 6.0 |  |  | 185.33 | Green | GREEN |  |  |  |  |  |  |
| 1347 | 1.4.2.3.5.3 | SIT Operational Testing End (all SIT PPs) (incl. confirmation that PPs have submitted their Test Completion Reports to Programme for assurance) | milestone | 0d | 2025-05-23 | 2025-05-23 | 1346FS+5d, 1341 | 2025-05-23 | 2025-05-23 | 0d | 2025-01-24 | 2025-01-24 | 60d | 0d |  | SI Test | PP | 6.0 | Roger Robar | Systems Integration Testing (SIT) | 217.71 | Green | AMBER | T3-TE-0050 | MHHS-ART081 |  | SITAG | T3 |  |
| 1348 | 1.4.2.3.5.4 | Assurance of PPs Test Completion Reports |  | 30d | 2025-04-21 | 2025-05-30 | 1347FF+5d | 2025-04-21 | 2025-05-30 | 30d | 2024-12-23 | 2025-01-31 | 60d | 0d |  | SI Test | PP | 5.0 | Roger Robar | Systems Integration Testing (SIT) | 185.33 | Green | GREEN |  |  |  |  |  |  |

Notes:
- 1328: Date missed due to lower than expected SIT functional test velocity. Forecast date updated and will be baselined once CR55 is approved.
- 1332: 16/09/24 - Date pushed back to 23/05/25, in line with recalibration exercise.
- 1337: 6/8/24: Date at risk due to lower than expected test velocity. Start of SIT-Non Functional (MVC) could be delayed. Programme-wide scenario re-planning underway
- 1340: 17/09/23 - Added new milestone
- 1343: Team has a dependency on Helix documentation that has been submitted late, which has impacted the approval of Theme 3 test scripts and test design. ~Date expected to move to 07/11/24.
- 1347: 16/09/24 - Date pushed back to 23/05/25, in line with recalibration exercise.

| ID | WBS | Task | Type | Duration | Start | Finish | Predecessors | Complete | Remaining | Baseline start | Baseline finish | Baseline duration | Baseline 1 start | Baseline 1 finish | Total slack | Free slack | Baseline cost | Responsible | Involved | Update Version | MHHS Resource Name | MHHS Programme Phase | Task Status | Sched Status | RAG | Artefact ID | Milestone ID | Text29 | Tier | Text3 |
| --- | --- | --- | --- | --- | --- | --- | --- | --- | --- | --- | --- | --- | --- | --- | --- | --- | --- | --- | --- | --- | --- | --- | --- | --- | --- | --- | --- | --- | --- | --- |
| 1349 | 1.4.2.3.5.5 | **SIT Operational Testing Test Completion Report (all SIT PPs)** |  | 20d | 2025-05-05 | 2025-05-30 |  |  |  | 2025-05-05 | 2025-05-30 | 20d | 2025-01-06 | 2025-01-31 | 60d |  |  | N/A | N/A | 5.0 | N/A | Systems Integration Testing (SIT) |  |  |  |  |  |  |  |  |
| 1350 | 1.4.2.3.5.5.1 | Develop document |  | 15d | 2025-05-05 | 2025-05-23 | 1347FF |  |  | 2025-05-05 | 2025-05-23 | 15d | 2025-01-06 | 2025-01-24 | 60d | 0d |  | SI Test |  | 5.0 | Roger Robar | Systems Integration Testing (SIT) | 199.33 | Green | GREEN |  |  |  |  |  |
| 1351 | 1.4.2.3.5.5.2 | Review & agree document |  | 5d | 2025-05-26 | 2025-05-30 | 1350, 1348FF |  |  | 2025-05-26 | 2025-05-30 | 5d | 2025-01-27 | 2025-01-31 | 60d | 0d |  | SI Test | PP,IPA | 5.0 | Roger Robar | Systems Integration Testing (SIT) | 220.33 | Green | GREEN |  |  |  |  |  |
| 1352 | 1.4.2.3.5.6 | SIT Operational Testing Test Completion Report (all SIT PPs) Approved | milestone | 0d | 2025-06-06 | 2025-06-06 | 1351FF+5d |  |  | 2025-06-06 | 2025-06-06 | 0d | 2025-02-07 | 2025-02-07 | 60d | 55d |  | SI Test | PP | 5.0 | Roger Robar | Systems Integration Testing (SIT) | 231.71 | Green | AMBER | MHHS-ART081 | T2-TE-0950 | SITAG | T2 |  |
| 1353 | 1.4.2.3.6 | **SIT MVC Test Exit Report** |  | 20d | 2025-07-14 | 2025-08-08 |  |  |  | 2025-07-14 | 2025-08-08 | 20d | 2025-01-06 | 2025-01-31 | 619d |  |  | N/A | N/A | 5.0 | N/A | Systems Integration Testing (SIT) |  |  |  |  |  |  |  |  |
| 1354 | 1.4.2.3.6.1 | Develop document |  | 15d | 2025-07-14 | 2025-08-01 | 1280FF |  |  | 2025-07-14 | 2025-08-01 | 15d | 2025-01-06 | 2025-01-24 | 619d | 0d |  | SI Test |  | 5.0 | Roger Robar | Systems Integration Testing (SIT) | 269.33 | Green | GREEN |  |  |  |  |  |
| 1355 | 1.4.2.3.6.2 | Review & agree document |  | 5d | 2025-08-04 | 2025-08-08 | 1354 |  |  | 2025-08-04 | 2025-08-08 | 5d | 2025-01-27 | 2025-01-31 | 619d |  |  | SI Test | PP,IPA | 5.0 | Roger Robar | Systems Integration Testing (SIT) | 290.33 | Green | GREEN |  |  |  |  |  |
| 1356 | 1.4.2.3.7 | SIT Minimum Viable Cohort Complete (SIT Minimum Viable Cohort Test Exit Report Approved) | milestone | 0d | 2025-08-22 | 2025-08-22 | 1240, 1282FS+5d, 1337, 1352 |  |  | 2025-08-22 | 2025-08-22 | 0d | 2025-02-07 | 2025-02-07 | 5d | 0d |  | CPT | PP,IPA | 5.0 | Roger Robar | Systems Integration Testing (SIT) | 308.71 | Green | AMBER | MHHS-ART081 | T1-TE-2000 | PSG | T1 |  |
| 1357 | 1.4.2.4 | **SIT (non-MVC)** |  | 119d? | 2025-06-16 A | 2025-11-27 |  | 10% | 106.64d? | 2025-05-05 | 2025-11-27 | 295d | 2024-03-11 | 2025-04-25 | 25d |  | -0 | N/A | N/A | 5.0 | N/A | Systems Integration Testing (SIT) | M10,M11 |  |  |  |  |  |  | D24D - NF Test Completion Report |
| 1358 | 1.4.2.4.1 | **SIT Functional Testing (non-MVC)** |  | 110d? | 2025-06-16 | 2025-11-14 |  |  |  | 2025-06-16 | 2025-11-14 | 295d | 2024-03-11 | 2025-04-25 | 25d |  |  | N/A | N/A | 5.0 | N/A | Systems Integration Testing (SIT) |  |  |  |  |  |  |  |  |
| 1359 | 1.4.2.4.1.1 | **SIT Functional Testing Execution (non-MVC)** |  | 95d? | 2025-06-16 | 2025-10-24 |  |  |  | 2025-06-16 | 2025-10-24 | 280d | 2024-03-11 | 2025-04-04 | 25d |  |  | N/A | N/A | 5.0 | N/A | Systems Integration Testing (SIT) | M10 |  |  |  |  |  |  | D24C - E2E Test Completion Report |
| 1360 | 1.4.2.4.1.1.1 | Test Execution (Cycle 3 Completion and Regression Testing) |  | 95d? | 2025-06-16 | 2025-10-24 | 1272 |  |  | 2025-06-16 | 2025-10-24 | 0d |  |  | 25d | 0d |  |  |  | 6.0 |  |  | 241.33 | Green | GREEN |  |  |  |  |  |
| 1361 | 1.4.2.4.1.1.2 | SIT Functional Testing End (non-MVC) (incl. confirmation that PPs have submitted their Test Completion Reports to Programme for assurance) | milestone | 0d | 2025-10-24 | 2025-10-24 | 1360FF |  |  | 2025-10-24 | 2025-10-24 | 0d | 2025-04-04 | 2025-04-04 | 25d | 0d |  | SI Test | PP | 5.0 | Roger Robar | Systems Integration Testing (SIT) | 371.71 | Green | AMBER | MHHS-ART072 | T3-TE-0052 | SITAG | T3 |  |
| 1362 | 1.4.2.4.1.2 | Assurance of PPs Test Completion Reports |  | 5d | 2025-11-03 | 2025-11-07 | 1361FS+5d |  |  | 2025-11-03 | 2025-11-07 | 5d | 2025-04-14 | 2025-04-18 | 25d | 0d |  | SI Test | PP | 5.0 | Roger Robar | Systems Integration Testing (SIT) | 381.33 | Green | GREEN |  |  |  |  |  |
| 1363 | 1.4.2.4.1.3 | **SIT Functional Testing Test Completion Report (non-MVC)** |  | 25d | 2025-10-06 | 2025-11-07 |  |  |  | 2025-10-06 | 2025-11-07 | 25d | 2025-03-17 | 2025-04-18 | 25d |  |  | N/A | N/A | 5.0 | N/A | Systems Integration Testing (SIT) |  |  |  |  |  |  |  |  |
| 1364 | 1.4.2.4.1.3.1 | Develop document |  | 15d | 2025-10-06 | 2025-10-24 | 1361FF |  |  | 2025-10-06 | 2025-10-24 | 15d | 2025-03-17 | 2025-04-04 | 30d | 5d |  | SI Test |  | 5.0 | Roger Robar | Systems Integration Testing (SIT) | 353.33 | Green | GREEN |  |  |  |  |  |
| 1365 | 1.4.2.4.1.3.2 | Review & agree document |  | 5d | 2025-11-03 | 2025-11-07 | 1364, 1362FF |  |  | 2025-11-03 | 2025-11-07 | 5d | 2025-04-14 | 2025-04-18 | 25d | 0d |  | SI Test | PP,IPA | 5.0 | Roger Robar | Systems Integration Testing (SIT) | 381.33 | Green | GREEN |  |  |  |  |  |
| 1366 | 1.4.2.4.1.4 | SIT Functional Testing Test Completion Report (non-MVC) Approved | milestone | 0d | 2025-11-14 | 2025-11-14 | 1365FF+5d |  |  | 2025-11-14 | 2025-11-14 | 0d | 2025-04-25 | 2025-04-25 | 25d | 0d |  | SI Test | PP | 5.0 | Roger Robar | Systems Integration Testing (SIT) | 392.71 | Green | AMBER | MHHS-ART072 | T3-TE-0055 | SITAG | T3 |  |
| 1367 | 1.4.2.4.2 | **SIT Migration Testing (non-MVC)** |  | 110d | 2025-06-16 A | 2025-11-14 |  | 23% | 85.25d | 2025-05-05 | 2025-10-08 | 230d | 2024-06-10 | 2025-04-25 | 25d |  |  | N/A | N/A | 5.0 | N/A | Systems Integration Testing (SIT) |  |  |  |  |  |  |  |  |
| 1368 | 1.4.2.4.2.1 | Test Execution (Cycle 3 Completion and Regression Testing) |  | 95d | 2025-06-16 A | 2025-10-24 | 1272 | 28% | 68d | 2025-05-05 | 2025-09-17 | 215d | 2024-06-10 | 2025-04-04 | 25d | 0d |  | SI Test | PP | 5.0 | Roger Robar | Systems Integration Testing (SIT) |  | Red | RED |  |  |  |  | D24E - Migration Test Completion Report |
| 1369 | 1.4.2.4.2.2 | SIT Migration Testing End (non-MVC) (incl. confirmation that PPs have submitted their Test Completion Reports to Programme for assurance) | milestone | 0d | 2025-10-24 | 2025-10-24 | 1368FF |  |  | 2025-09-17 | 2025-09-17 | 0d | 2025-04-04 | 2025-04-04 | 25d | 0d |  | SI Test | PP | 5.0 | Roger Robar | Systems Integration Testing (SIT) | 371.71 | Red | RED | MHHS-ART076 | T3-TE-0051 | SITAG | T3 |  |
| 1370 | 1.4.2.4.2.3 | Assurance of PPs Test Completion Reports |  | 5d | 2025-11-03 | 2025-11-07 | 1369FS+5d |  |  | 2025-09-25 | 2025-10-01 | 5d | 2025-04-14 | 2025-04-18 | 25d | 0d |  | SI Test | PP | 5.0 | Roger Robar | Systems Integration Testing (SIT) | 381.33 | Red | RED |  |  |  |  |  |
| 1371 | 1.4.2.4.2.4 | **SIT Migration Testing Test Completion Report (non-MVC)** |  | 25d | 2025-10-06 | 2025-11-07 |  |  |  | 2025-08-28 | 2025-10-01 | 25d | 2025-03-17 | 2025-04-18 | 25d |  |  | N/A | N/A | 5.0 | N/A | Systems Integration Testing (SIT) |  |  |  |  |  |  |  |  |
| 1372 | 1.4.2.4.2.4.1 | Develop document |  | 15d | 2025-10-06 | 2025-10-24 | 1369FF |  |  | 2025-08-28 | 2025-09-17 | 15d | 2025-03-17 | 2025-04-04 | 30d | 5d |  | SI Test |  | 5.0 | Roger Robar | Systems Integration Testing (SIT) | 353.33 | Red | RED |  |  |  |  |  |
| 1373 | 1.4.2.4.2.4.2 | Review & agree document |  | 5d | 2025-11-03 | 2025-11-07 | 1372, 1370FF |  |  | 2025-09-25 | 2025-10-01 | 5d | 2025-04-14 | 2025-04-18 | 25d | 0d |  | SI Test | PP,IPA | 5.0 | Roger Robar | Systems Integration Testing (SIT) | 381.33 | Red | RED |  |  |  |  |  |
| 1374 | 1.4.2.4.2.5 | SIT Migration Testing Test Completion Report (non-MVC Approved) | milestone | 0d | 2025-11-14 | 2025-11-14 | 1373FF+5d |  |  | 2025-10-08 | 2025-10-08 | 0d | 2025-04-25 | 2025-04-25 | 25d | 0d |  | SI Test | PP | 5.0 | Roger Robar | Systems Integration Testing (SIT) | 392.71 | Red | RED | MHHS-ART076 | T3-TE-0056 | SITAG | T3 |  |

Notes:
- 1352: 6/8/24: Date at risk due to lower than expected test velocity. Start of SIT Operational (MVC) could be delayed. Programme-wide scenario re-planning underway
- 1356: 6/8/24: Date at risk due to lower than expected test velocity. Start of SIT Operational (MVC) could be delayed. Programme-wide scenario re-planning underway
- 1361: 6/8/24: Date at risk due to lower than expected test velocity. Completion of SIT Functional Testing (Other Participants) could be delayed. Programme-wide scenario re-planning underway
- 1362: 6/8/24: Date at risk due to lower than expected test velocity. Completion of SIT Functional Testing (Other Participants) could be delayed. Programme-wide scenario re-planning underway
- 1364: 6/8/24: Date at risk due to lower than expected test velocity. Completion of SIT Functional Testing (Other Participants) could be delayed. Programme-wide scenario re-planning underway
- 1365: 6/8/24: Date at risk due to lower than expected test velocity. Completion of SIT Functional Testing (Other Participants) could be delayed. Programme-wide scenario re-planning underway
- 1366: 6/8/24: Date at risk due to lower than expected test velocity. Completion of SIT Functional Testing (Other Participants) could be delayed. Programme-wide scenario re-planning underway
- 1369: 6/8/24: Date at risk due to lower than expected test velocity. Completion of SIT Migration Testing (Other Participants) could be delayed. Programme-wide scenario re-planning underway
- 1374: 6/8/24: Date at risk due to lower than expected test velocity. Completion of SIT Migration Testing (Other Participants) could be delayed. Programme-wide scenario re-planning underway

| ID | WBS | Task | Type | Duration | Start | Finish | Predecessors | Complete | Remaining | Baseline start | Baseline finish | Baseline duration | Baseline 1 start | Baseline 1 finish | Total slack | Free slack | Constraint | Baseline cost | Responsible | Involved | Update Version | MHHS Resource Name | MHHS Programme Phase | Task Status | Sched Status | RAG | Artefact ID | Milestone ID | Text29 | Tier |
| --- | --- | --- | --- | --- | --- | --- | --- | --- | --- | --- | --- | --- | --- | --- | --- | --- | --- | --- | --- | --- | --- | --- | --- | --- | --- | --- | --- | --- | --- | --- |
| 1375 | 1.4.2.4.3 | **SIT non-MVC Test Exit Report** |  | 20d | 2025-10-27 | 2025-11-21 |  |  |  | 2025-10-27 | 2025-11-21 | 20d | 2025-03-17 | 2025-04-11 | 25d |  |  |  | N/A | N/A | 5.0 | N/A | Systems Integration Testing (SIT) |  |  |  |  |  |  |  |
| 1376 | 1.4.2.4.3.1 | Develop document |  | 15d | 2025-10-27 | 2025-11-14 | 1366FF, 1374FF |  |  | 2025-10-27 | 2025-11-14 | 15d | 2025-03-17 | 2025-04-04 | 25d | 0d |  |  | SI Test |  | 5.0 | Roger Robar | Systems Integration Testing (SIT) | 374.33 | Green | GREEN |  |  |  |  |
| 1377 | 1.4.2.4.3.2 | Review & agree document |  | 5d | 2025-11-17 | 2025-11-21 | 1376 |  |  | 2025-11-17 | 2025-11-21 | 5d | 2025-04-07 | 2025-04-11 | 25d | 0d |  |  | SI Test | PP,IPA | 5.0 | Roger Robar | Systems Integration Testing (SIT) | 395.33 | Green | GREEN |  |  |  |  |
| 1378 | 1.4.2.4.4 | SIT non-MVC Complete | milestone | 0d | 2025-11-27 | 2025-11-27 | 1377FS+4d, 1366, 1374 |  |  | 2025-11-27 | 2025-11-27 | 0d | 2025-04-21 | 2025-04-21 | 25d | 0d |  |  | SI Test | PP | 5.27 | Roger Robar | Systems Integration Testing (SIT) | 405.71 | Green | AMBER | MHHS-ART081 | T3-TE-0059 | SITAG | T3 |
| 1379 | 1.4.3 | **UIT Environment Preparation** |  | 700d? | 2022-10-31 A | 2025-07-04 |  | 46% | 377.74d? | 2022-10-31 | 2025-07-04 | 680d | 2022-10-31 | 2025-06-06 | 644d |  |  | -0 | N/A | N/A | 5.0 | N/A | Systems Integration Testing (SIT) |  |  |  |  |  |  |  |
| 1380 | 1.4.3.1 | **Test Artefact Development** |  | 556d? | 2023-03-01 A | 2025-04-16 |  | 51% | 270.06d? | 2023-03-01 | 2024-07-18 | 361d | 2023-03-01 | 2023-08-04 | 701d |  |  | -0 | N/A | N/A | 5.0 | N/A | Systems Integration Testing (SIT) |  |  |  |  |  |  |  |
| 1381 | 1.4.3.1.1 | **E2E Sandbox Guidance** |  | 539d? | 2023-03-01 A | 2025-03-24 |  | 71% | 158.53d? | 2023-03-01 | 2024-07-18 | 361d | 2023-03-01 | 2023-08-04 | 718d |  |  | -0 | N/A | N/A | 5.0 | N/A | Systems Integration Testing (SIT) |  |  |  |  |  |  |  |
| 1382 | 1.4.3.1.1.1 | Develop document |  | 83d | 2023-03-01 A | 2023-06-23 A |  | 100% |  | 2023-03-01 | 2023-06-23 | 83d | 2023-03-01 | 2023-06-23 |  |  | start no earlier than 2023-03-01 |  | SI Test |  | 5.0 | Stuart Scott | Systems Integration Testing (SIT) |  | Complete | COMPLETE |  |  |  |  |
| 1383 | 1.4.3.1.1.2 | Artefact review (via SITAG) and updates |  | 25d | 2023-06-26 A | 2023-07-28 A | 1382 | 100% |  | 2023-06-26 | 2023-07-28 | 25d | 2023-06-26 | 2023-07-28 |  |  |  |  | SI Test | PP,IPA | 5.0 | Stuart Scott | Systems Integration Testing (SIT) |  | Complete | COMPLETE |  |  |  |  |
| 1384 | 1.4.3.1.1.3 | E2E Sandbox Guidance approved | milestone | 0d | 2024-07-18 A | 2024-07-18 A | 1383FF+5d | 100% |  | 2024-07-18 | 2024-07-18 | 0d | 2023-08-04 | 2023-08-04 |  |  | start no earlier than 2024-07-18 |  | SI Test | PP | 5.29 | Stuart Scott | Systems Integration Testing (SIT) |  | Complete | COMPLETE | MHHS-ART154 | T3-TE-0067 | QAG | T3 |
| 1385 | 1.4.3.1.1.4 | Update E2E Sandbox guidance to reflect CR55 |  | 29d | 2025-01-13 | 2025-02-20 |  |  |  |  |  |  |  |  | 718d | 0d | start no earlier than 2025-01-13 |  |  |  | 6.1 |  |  | 87.33 | No BL | GREEN |  |  |  |  |
| 1386 | 1.4.3.1.1.5 | Internal SI review |  | 5d | 2025-02-21 | 2025-02-27 | 1385 |  |  |  |  |  |  |  | 718d | 0d |  |  |  |  | 6.1 |  |  | 126.33 | No BL | GREEN |  |  |  |  |
| 1387 | 1.4.3.1.1.6 | SRO / Code Bodies review |  | 5d | 2025-02-28 | 2025-03-06 | 1386 |  |  |  |  |  |  |  | 718d | 0d |  |  |  |  | 6.1 |  |  | 133.33 | No BL | GREEN |  |  |  |  |
| 1388 | 1.4.3.1.1.7 | Submit version to QWG |  | 3d | 2025-03-07 | 2025-03-11 | 1387 |  |  |  |  |  |  |  | 718d | 0d |  |  |  |  | 6.1 |  |  | 140.33 | No BL | GREEN |  |  |  |  |
| 1389 | 1.4.3.1.1.8 | Artefact Approval (via QWG) | milestone | 0d | 2025-03-11 | 2025-03-11 | 1388 |  |  |  |  |  |  |  | 718d | 0d |  |  |  |  | 6.1 |  |  | 144.71 | No BL | GREEN |  |  |  |  |
| 1390 | 1.4.3.1.1.9 | Final Document updates post QWG review |  | 1d? | 2025-03-13 | 2025-03-13 | 1389FS+1d |  |  |  |  |  |  |  | 718d | 0d |  |  |  |  | 6.1 |  |  | 146.33 | No BL | GREEN |  |  |  |  |
| 1391 | 1.4.3.1.1.10 | Submit final version to QAG |  | 1d? | 2025-03-17 | 2025-03-17 | 1390FS+1d |  |  |  |  |  |  |  | 718d | 0d |  |  |  |  | 6.1 |  |  | 150.33 | No BL | GREEN |  |  |  |  |
| 1392 | 1.4.3.1.1.11 | E2E Sandbox guidance update approved |  | 1d? | 2025-03-24 | 2025-03-24 | 1391FS+4d |  |  |  |  |  |  |  | 718d |  |  |  |  |  | 6.1 |  |  | 157.33 | No BL | GREEN |  |  |  |  |
| 1393 | 1.4.3.1.2 | **E2E Sandbox Test Data Approach & Plan** |  | 68d | 2025-01-13 | 2025-04-16 |  |  |  | 2023-12-05 | 2024-05-09 | 93d | 2023-03-29 | 2023-08-04 | 701d |  |  |  | N/A | N/A | 5.0 | N/A | Systems Integration Testing (SIT) |  |  |  |  |  |  |  |
| 1394 | 1.4.3.1.2.1 | Develop document |  | 27d | 2025-01-13 | 2025-02-18 | 1382SS+199d |  |  | 2023-12-05 | 2024-03-15 | 68d | 2023-03-29 | 2023-06-30 | 701d | 0d | start no earlier than 2025-01-13 |  | SI Test |  | 5.0 | Stuart Scott | Systems Integration Testing (SIT) | 87.33 | Red | RED |  |  |  |  |
| 1395 | 1.4.3.1.2.2 | Internal SI review and updates |  | 5d | 2025-02-19 | 2025-02-25 | 1394 |  |  | 2024-03-11 | 2024-03-15 | 0d |  |  | 701d | 0d |  |  |  |  | 6.1 |  |  | 124.33 | Red | RED |  |  |  |  |
| 1396 | 1.4.3.1.2.3 | SRO / Code Bodies review |  | 5d | 2025-02-26 | 2025-03-04 | 1395 |  |  | 2024-03-18 | 2024-03-22 | 0d |  |  | 701d | 0d |  |  |  |  | 6.1 |  |  | 131.33 | Red | RED |  |  |  |  |
| 1397 | 1.4.3.1.2.4 | Submit proposed version to QWG | milestone | 0d | 2025-03-04 | 2025-03-04 | 1396 |  |  | 2025-03-04 | 2025-03-04 | 0d |  |  | 701d | 0d |  |  |  |  | 6.1 |  |  | 137.71 | Green | GREEN |  |  |  |  |
| 1398 | 1.4.3.1.2.5 | Discuss document at QWG | milestone | 0d | 2025-03-11 | 2025-03-11 | 1397FS+5d |  |  | 2025-03-11 | 2025-03-11 | 0d |  |  | 701d | 0d |  |  |  |  | 6.1 |  |  | 144.71 | Green | GREEN |  |  |  |  |
| 1399 | 1.4.3.1.2.6 | Final updates prior to consultation |  | 4d | 2025-03-12 | 2025-03-17 | 1398 |  |  | 2024-03-25 | 2024-03-29 | 0d |  |  | 701d | 0d |  |  |  |  | 6.1 |  |  | 145.33 | Red | RED |  |  |  |  |
| 1400 | 1.4.3.1.2.7 | Industry Consultation for E2E Sandbox Test Data Approach and Plan document |  | 10d | 2025-03-18 | 2025-03-31 | 1399 |  |  | 2024-04-01 | 2024-04-12 | 0d |  |  | 701d | 0d |  |  |  |  | 6.1 |  |  | 151.33 | Red | RED |  |  |  |  |
| 1401 | 1.4.3.1.2.8 | Document updates post Industry Consultation |  | 3d | 2025-04-01 | 2025-04-03 | 1400 |  |  | 2024-04-15 | 2024-04-22 | 0d |  |  | 701d | 0d | finish no earlier than 2024-04-22 |  |  |  | 6.1 |  |  | 165.33 | Red | RED |  |  |  |  |
| 1402 | 1.4.3.1.2.9 | Submit Proposed Version to QWG |  | 3d | 2025-04-04 | 2025-04-08 | 1401 |  |  | 2024-04-23 | 2024-04-23 | 0d |  |  | 701d | 0d |  |  |  |  | 6.1 |  |  | 168.33 | Red | RED |  |  |  |  |
| 1403 | 1.4.3.1.2.10 | Artefact Approval (via QWG) | milestone | 0d | 2025-04-08 | 2025-04-08 | 1402 |  |  | 2024-04-30 | 2024-04-30 | 0d |  |  | 701d | 0d |  |  |  |  | 6.1 |  |  | 172.71 | Red | RED |  |  |  |  |
| 1404 | 1.4.3.1.2.11 | Final Document updates post QWG review | milestone | 0d | 2025-04-09 | 2025-04-09 | 1403FS+1d |  |  | 2024-05-01 | 2024-05-01 | 0d |  |  | 701d | 0d | start no earlier than 2024-05-01 |  |  |  | 6.1 |  |  | 173.71 | Red | RED |  |  |  |  |
| 1405 | 1.4.3.1.2.12 | Submit final version to QAG | milestone | 0d | 2025-04-10 | 2025-04-10 | 1404FS+1d |  |  | 2024-05-02 | 2024-05-02 | 0d |  |  | 701d | 0d | start no earlier than 2024-05-02 |  |  |  | 6.1 |  |  | 174.71 | Red | RED |  |  |  |  |
| 1406 | 1.4.3.1.2.13 | E2E Sandbox Test Data Approach and Plan | milestone | 0d | 2025-04-16 | 2025-04-16 | 1405FS+4d |  |  | 2024-05-09 | 2024-05-09 | 0d |  |  | 701d |  | start no earlier than 2024-05-09 |  |  |  | 6.1 |  |  | 180.71 | Red | RED |  | T3-QU-0124 |  |  |

Notes:
- 1376: 6/8/24: Date at risk due to lower than expected test velocity. Completion of SIT- Other Particiapnts Test Exit report could be delayed. Programme-wide scenario re-planning underway
- 1377: 6/8/24: Date at risk due to lower than expected test velocity. Completion of SIT- Other Particiapnts Test Exit report could be delayed. Programme-wide scenario re-planning underway
- 1378: 6/8/24: Date at risk due to lower than expected test velocity. Completion of SIT- Other Particiapnts Test Exit report could be delayed. Programme-wide scenario re-planning underway
- 1384: 26/6: Baseline date change approved at QAG on 20/6/24. 11/7/24: Date change approved at QAG on 20/6/24 from 4/08/24 to 18/7/24

| ID | WBS | Task | Type | Duration | Start | Finish | Predecessors | Complete | Remaining | Baseline start | Baseline finish | Baseline duration | Baseline 1 start | Baseline 1 finish | Total slack | Free slack | Constraint | Baseline cost | Responsible | Involved | Update Version | MHHS Resource Name | MHHS Programme Phase | Sched Status | RAG | Artefact ID | Task Status | Milestone ID | Text29 | Tier |
| --- | --- | --- | --- | --- | --- | --- | --- | --- | --- | --- | --- | --- | --- | --- | --- | --- | --- | --- | --- | --- | --- | --- | --- | --- | --- | --- | --- | --- | --- | --- |
| 1407 | 1.4.3.2 | **UIT Stub Specification and Delivery** |  | 230d | 2023-12-04 A | 2024-10-18 |  | 89% | 25.35d | 2023-12-04 | 2024-10-18 | 190d | 2023-10-27 | 2024-08-23 | 829d |  |  | -0 | N/A | N/A | 5.0 | N/A | Systems Integration Testing (SIT) |  |  |  |  |  |  |  |
| 1408 | 1.4.3.2.1 | **Qualification Test Stubs** |  | 230d | 2023-12-04 A | 2024-10-18 |  | 89% | 25.35d | 2023-12-04 | 2024-10-18 | 190d | 2023-10-27 | 2024-08-23 | 829d |  |  | -0 | N/A | N/A | 5.16 | N/A | Systems Integration Testing (SIT) |  |  |  |  |  |  |  |
| 1409 | 1.4.3.2.1.1 | Specify |  | 44d | 2023-12-04 A | 2024-02-01 A | 508FS+13d | 100% |  | 2023-12-04 | 2024-02-01 | 44d | 2023-10-27 | 2023-12-29 |  |  |  |  | SI DevOps | Qualification,SRO | 5.0 | Matthew Bray | Systems Integration Testing (SIT) | Complete | COMPLETE |  |  |  |  |  |
| 1410 | 1.4.3.2.1.2 | Build & Test |  | 141d | 2024-02-02 A | 2024-08-16 | 1409 | 90% | 14.1d | 2024-02-02 | 2024-08-16 | 141d | 2023-12-29 | 2024-05-24 | 33.75d | 0d |  |  | SI DevOps | Qualification,SRO | 5.23 | Matthew Bray | Systems Integration Testing (SIT) | Overdue | RED |  |  |  |  |  |
| 1411 | 1.4.3.2.1.3 | Prepare for release |  | 45d | 2024-08-19 A | 2024-10-18 | 1410 | 75% | 11.25d | 2024-08-19 | 2024-10-18 | 5d | 2024-07-29 | 2024-08-23 | 829d | 0d |  |  | SI DevOps | Qualification,SRO | 5.0 | Matthew Bray | Systems Integration Testing (SIT) | Green | GREEN |  |  |  |  |  |
| 1412 | 1.4.3.2.1.4 | Non-SIT LDSO Test Harness Released | milestone | 0d | 2024-10-18 | 2024-10-18 | 1411 |  |  | 2024-10-18 | 2024-10-18 | 0d | 2024-08-23 | 2024-08-23 | 829d |  |  |  | SI DevOps | Qualification,SRO | 5.27 | Matthew Bray | Systems Integration Testing (SIT) | Green | RED | MHHS-ART080 | 0.71 | T3-TE-0035 | QAG | T3 |
| 1413 | 1.4.3.3 | **Environments (UIT)** |  | 700d | 2022-10-31 A | 2025-07-04 |  | 44% | 389.54d | 2022-10-31 | 2025-07-04 | 680d | 2022-10-31 | 2025-06-06 | 644d |  |  | -0 | N/A | N/A | 5.0 | N/A | Systems Integration Testing (SIT) |  |  |  |  |  |  |  |
| 1414 | 1.4.3.3.1 | **Central Party (Avenade) Environments (UIT)** |  | 488d | 2022-11-16 A | 2024-09-27 |  | 97% | 14.82d | 2022-11-16 | 2024-09-27 | 493d | 2022-11-16 | 2024-10-04 | 844d |  |  | -0 | N/A | N/A | 5.28 | N/A | Systems Integration Testing (SIT) |  |  |  |  |  |  |  |
| 1415 | 1.4.3.3.1.1 | Central Party (Avendae) environment preparation (incl. security certificates and security compliance) |  | 447d | 2022-11-16 A | 2024-08-01 A | 504 | 100% |  | 2022-11-16 | 2024-08-01 | 463d | 2022-11-16 | 2024-08-23 |  |  |  |  | PP | SI Test | 5.28 | Simon Berry | Systems Integration Testing (SIT) | Complete | COMPLETE |  |  |  |  |  |
| 1416 | 1.4.3.3.1.2 | Submit self-declaration of environment preparation complete (incl. security certificates and security compliance) to Programme for assurance |  | 447d | 2022-11-16 A | 2024-08-01 A | 1415SS | 100% |  | 2022-11-16 | 2024-08-01 | 463d | 2022-11-16 | 2024-08-23 |  |  |  |  | PP | SI Test | 5.28 | Simon Berry | Systems Integration Testing (SIT) | Complete | COMPLETE |  |  |  |  |  |
| 1417 | 1.4.3.3.1.3 | Central Party (Avenade) UIT environment connectivity proving |  | 25d | 2024-08-26 | 2024-09-27 | 1429 |  |  | 2024-08-26 | 2024-09-27 | 25d | 2024-08-27 | 2024-09-20 | 843d | 0d |  |  | PP | SI Test | 5.28 | Simon Berry | Systems Integration Testing (SIT) | Green | GREEN |  | -52.67 |  |  |  |
| 1418 | 1.4.3.3.1.4 | Deployment of MHHS solution code to UIT environments |  | 2d | 2024-07-29 | 2024-07-30 |  |  |  | 2024-07-29 | 2024-07-30 | 10d | 2024-09-09 | 2024-09-20 | 886d | 0d | start no earlier than 2024-07-29 |  | PP | SI Test | 5.28 | Simon Berry | Systems Integration Testing (SIT) | Overdue Start | RED |  | -80.67 |  |  |  |
| 1419 | 1.4.3.3.1.5 | Central Party (Avenade) UIT environment Regression Testing |  | 1d | 2024-07-31 | 2024-07-31 | 1418 |  |  | 2024-07-31 | 2024-07-31 | 10d | 2024-09-23 | 2024-10-04 | 886d |  |  |  | PP | SI Test | 5.28 | Simon Berry | Systems Integration Testing (SIT) | Overdue Start | RED |  | -78.67 |  |  |  |
| 1420 | 1.4.3.3.2 | **E2E Sandbox Participants (UIT)** |  | 680d | 2022-10-31 | 2025-06-06 |  |  |  | 2022-10-31 | 2025-06-06 | 680d | 2022-10-31 | 2025-06-06 | 0d |  |  |  | N/A | N/A | 5.0 | N/A | Systems Integration Testing (SIT) |  |  |  |  |  |  |  |
| 1421 | 1.4.3.3.2.1 | E2E Sandbox Participants environment preparation (incl. security certificates and security compliance) |  | 660d | 2022-10-31 | 2025-05-09 |  |  |  | 2022-10-31 | 2025-05-09 | 660d | 2022-10-31 | 2025-05-09 | 0d |  | must finish on 2025-05-09 |  | PP | SI Test | 5.0 | Simon Berry | Systems Integration Testing (SIT) | Overdue Start | GREEN |  | -717.67 |  |  |  |
| 1422 | 1.4.3.3.2.2 | Submit self-declaration of environment preparation complete (incl. security certificates and security compliance) to Programme for assurance |  | 660d | 2022-10-31 | 2025-05-09 |  |  |  | 2022-10-31 | 2025-05-09 | 660d | 2022-10-31 | 2025-05-09 | 664d | 0d |  |  | PP | SI Test | 5.0 | Simon Berry | Systems Integration Testing (SIT) | Overdue Start | GREEN |  | -717.67 |  |  |  |
| 1423 | 1.4.3.3.2.3 | E2E Sandbox Participants UIT environment connectivity proving |  | 20d | 2025-05-12 | 2025-06-06 | 1422 |  |  | 2025-05-12 | 2025-06-06 | 20d | 2025-05-12 | 2025-06-06 | 664d | 0d |  |  | PP | SI Test | 5.0 | Simon Berry | Systems Integration Testing (SIT) | Green | GREEN |  | 206.33 |  |  |  |
| 1424 | 1.4.3.3.2.4 | Deployment of MHHS solution code to UIT environments |  | 10d | 2025-05-26 | 2025-06-06 | 1423FF |  |  | 2025-05-26 | 2025-06-06 | 10d | 2025-05-26 | 2025-06-06 | 664d |  |  |  | PP | SI Test | 5.0 | Simon Berry | Systems Integration Testing (SIT) | Green | GREEN |  | 220.33 |  |  |  |
| 1425 | 1.4.3.3.2.5 | Coordinate E2E Sandbox Participants' UIT environment preparation (for E2E Sandbox Testing Start) |  | 463d | 2022-10-31 | 2024-08-07 | 1421SS |  |  | 2022-10-31 | 2024-08-07 | 463d | 2022-10-31 | 2024-08-07 | 881d |  |  |  | SI Test | PP | 5.0 | Simon Berry | Systems Integration Testing (SIT) | Overdue Start | RED |  | -717.67 |  |  |  |
| 1426 | 1.4.3.3.3 | **SI Environments (UIT)** |  | 688d | 2022-11-16 A | 2025-07-04 |  | 69% | 215.33d | 2022-11-16 | 2025-07-04 | 680d | 2022-10-31 | 2025-06-06 | 644d |  |  |  | N/A | N/A | 5.0 | N/A | Systems Integration Testing (SIT) |  |  |  |  |  |  |  |
| 1427 | 1.4.3.3.3.1 | Coordinate Central Parties' UIT environment preparation |  | 447d | 2022-11-16 A | 2024-08-01 A | 1415SS | 100% |  | 2022-11-16 | 2024-08-01 | 463d | 2022-11-16 | 2024-08-23 |  |  |  |  | SI Test | PP | 5.0 | Simon Berry | Systems Integration Testing (SIT) | Complete | COMPLETE |  |  |  |  |  |
| 1428 | 1.4.3.3.3.2 | Assure Central Parties' self-declaration of environment preparation complete (incl. security certificates and security compliance) |  | 463d | 2022-11-16 A | 2024-08-23 | 1416SS | 97% | 12d | 2022-11-16 | 2024-08-23 | 463d | 2022-11-16 | 2024-08-23 | 869d |  |  |  | SI Test | PP | 5.0 | Simon Berry | Systems Integration Testing (SIT) | Overdue | RED |  |  |  |  |  |
| 1429 | 1.4.3.3.3.3 | Central Parties' UIT environments ready to start connectivity proving (incl. certificates and security compliance) | milestone | 0d | 2024-08-23 A | 2024-08-23 A | 1412 | 100% |  | 2024-08-23 | 2024-08-23 | 0d | 2024-08-23 | 2024-08-23 |  |  |  |  | SI Test | PP | 5.0 | Simon Berry | Systems Integration Testing (SIT) | Complete | COMPLETE |  |  | T3-TE-0044 | QAG | T3 |
| 1430 | 1.4.3.3.3.4 | Coordinate Central Parties' UIT environment connectivity proving |  | 26d | 2024-08-26 | 2024-09-30 | 1417SS |  |  | 2024-08-26 | 2024-09-30 | 19d | 2025-05-12 | 2025-06-05 | 843d |  |  |  | SI Test | PP | 5.0 | Simon Berry | Systems Integration Testing (SIT) | Green | GREEN |  | -52.67 |  |  |  |
| 1431 | 1.4.3.3.3.5 | Coordinate deployment of MHHS solution code to Central Parties' UIT environments |  | 2d | 2024-07-29 A | 2024-07-30 A | 1418SS | 100% |  | 2024-07-29 | 2024-07-30 | 10d | 2025-05-26 | 2025-06-06 |  |  |  |  | SI Test | PP | 5.0 | Simon Berry | Systems Integration Testing (SIT) | Complete | COMPLETE |  |  |  |  |  |
| 1432 | 1.4.3.3.3.6 | Coordinate Central Parties' UIT environment Regression Testing |  | 1d | 2024-07-31 | 2024-07-31 | 1431 |  |  | 2024-07-31 | 2024-07-31 | 10d | 2024-09-23 | 2024-10-04 | 886d |  |  |  | SI Test | PP | 5.0 | Simon Berry | Systems Integration Testing (SIT) | Overdue Start | RED |  | -78.67 |  |  |  |

Notes:
- 1410: 30/4: Removed previous testing phases as were no longer relevant and extended task to push out to align with existing dates
- 1412: Date will be missed due to Sims & Ems being blocked from completing connectivity and regression testing activities, since message functionality is disabled in the current UIT environment version (IR7.3), only becoming enabled from 2/9 (release of IR8.1 UIT). Decision not to seek milestone date change and RAG as red was requested by SRO, with a corresponding acknowledgement that Sims & Ems are blocked due to external factors. LDP working towards getting the milestone date changed to September (exact date TBC). / Notes (2): 9/8/24: the meantime, and acknowledges that the reason for this is due to external factors (being blocked from completing final delivery activities due to UIT functionality until September) rather than S&E missing the deadline
- 1414: 8/7/24: Updated to reflect Avende are the only PP

| ID | WBS | Task | Type | Duration | Start | Finish | Predecessors | Baseline start | Baseline finish | Baseline duration | Baseline 1 start | Baseline 1 finish | Total slack | Free slack | Constraint | Responsible | Involved | Update Version | MHHS Resource Name | MHHS Programme Phase | Task Status | Sched Status | RAG | Artefact ID | Milestone ID | Text29 | Tier |
| --- | --- | --- | --- | --- | --- | --- | --- | --- | --- | --- | --- | --- | --- | --- | --- | --- | --- | --- | --- | --- | --- | --- | --- | --- | --- | --- | --- |
| 1433 | 1.4.3.3.3.7 | **Environments (Non-SIT LDSO)** |  | 43d | 2024-08-01 | 2024-09-30 |  | 2024-08-01 | 2024-09-30 | 115d | 2024-08-06 | 2025-01-13 | 843d |  |  | N/A | N/A | 5.28 | N/A | Qualification |  |  |  |  |  |  |  |
| 1434 | 1.4.3.3.3.7.1 | Coordinate Qualification Participants' environment preparation |  | 17d | 2024-08-01 | 2024-08-23 |  | 2024-08-01 | 2024-08-23 | 60d | 2024-08-06 | 2024-10-28 | 869d |  | start no earlier than 2024-08-01 | SI Test | Code Bodies, PP | 5.28 | Simon Berry | Qualification | -77.67 | Overdue Start | RED |  |  |  |  |
| 1435 | 1.4.3.3.3.7.2 | Coordinate deployment of MHHS solution code to Qualification Participants' UIT environments |  | 17d | 2024-08-01 | 2024-08-23 |  | 2024-08-01 | 2024-08-23 | 10d | 2024-10-15 | 2024-10-28 | 843d | 0d | start no earlier than 2024-08-01 | SI Test | Code Bodies, PP | 5.28 | Simon Berry | Qualification | -77.67 | Overdue Start | RED |  |  |  |  |
| 1436 | 1.4.3.3.3.7.3 | Qualification Testing Tranche 1 Participants' UIT environments ready to start connectivity proving (incl. certificates and security compliance) | milestone | 0d | 2024-08-26 | 2024-08-26 | 1435FS+1d | 2024-08-26 | 2024-08-26 | 0d | 2024-11-04 | 2024-11-04 | 843d | 0d |  | SI Test | Code Bodies, PP, IPA | 5.28 | Simon Berry | Qualification | -52.29 | Green | GREEN | MHHS-ART073 | T3-QU-0017 | QAG | T3 |
| 1437 | 1.4.3.3.3.7.4 | **Coordinate Qualification Participants' connectivity proving (Non-SIT LDSO)** |  | 25d | 2024-08-27 | 2024-09-30 |  | 2024-08-27 | 2024-09-30 | 50d | 2024-11-05 | 2025-01-13 | 843d |  |  | N/A | N/A | 5.0 | N/A | Qualification |  |  |  |  |  |  |  |
| 1438 | 1.4.3.3.3.7.4.1 | Assurance of Qualification Participants' connectivity proving |  | 25d | 2024-08-27 | 2024-09-30 | 1436 | 2024-08-27 | 2024-09-30 | 50d | 2024-11-05 | 2025-01-13 | 843d |  |  | SI Test | Code Bodies, PP | 5.0 |  | Qualification | -51.67 | Green | GREEN |  |  |  |  |
| 1439 | 1.4.3.3.3.8 | **Environments (S&A) Wave 1** |  | 41d | 2024-08-01 | 2024-09-26 |  | 2024-08-01 | 2024-09-26 | 115d | 2024-08-06 | 2025-01-13 |  |  |  | N/A | N/A | 5.28 | N/A | Qualification |  |  |  |  |  |  |  |
| 1440 | 1.4.3.3.3.8.1 | Coordinate Qualification Participants' environment preparation |  | 20d | 2024-09-02 | 2024-09-27 |  | 2024-09-02 | 2024-09-27 | 60d | 2024-08-06 | 2024-10-28 | 844d |  | start no earlier than 2024-09-02 | SI Test | Code Bodies, PP | 5.28 | Simon Berry | Qualification | -45.67 | Green | GREEN |  |  |  |  |
| 1441 | 1.4.3.3.3.8.2 | Coordinate deployment of MHHS solution code to Qualification Participants' UIT environments |  | 10d | 2024-10-21 | 2024-11-01 |  | 2024-10-21 | 2024-11-01 | 10d | 2024-10-15 | 2024-10-28 | 774d | 0d | start no earlier than 2024-10-21 | SI Test | Code Bodies, PP | 5.28 | Simon Berry | Qualification | 3.33 | Green | GREEN |  |  |  |  |
| 1442 | 1.4.3.3.3.8.3 | Qualification Testing Wave 1 Participants' UIT environments ready to start connectivity proving (incl. certificates and security compliance) |  | 19d | 2024-11-05 | 2024-11-29 | 1441FS+1d | 2024-11-05 | 2024-11-29 | 0d | 2024-11-04 | 2024-11-04 | 774d | 0d |  | SI Test | Code Bodies, PP, IPA | 5.28 | Simon Berry | Qualification | 18.33 | Green | GREEN | MHHS-ART073 | New? | QAG | T3 |
| 1443 | 1.4.3.3.3.8.4 | **Coordinate Qualification Participants' connectivity proving (S&A)** |  | 25d | 2024-12-02 | 2025-01-03 |  | 2024-12-02 | 2025-01-03 | 50d | 2024-11-05 | 2025-01-13 | 774d |  |  | N/A | N/A | 5.0 | N/A | Qualification |  |  |  |  |  |  |  |
| 1444 | 1.4.3.3.3.8.4.1 | Assurance of Qualification Participants' connectivity proving |  | 25d | 2024-12-02 | 2025-01-03 | 1442 | 2024-12-02 | 2025-01-03 | 50d | 2024-11-05 | 2025-01-13 | 774d |  |  | SI Test | Code Bodies, PP | 5.0 |  | Qualification | 45.33 | Green | GREEN |  |  |  |  |
| 1445 | 1.4.3.3.3.9 | **Environments (S&A) Wave 2** |  | 139d | 2024-08-27 | 2025-03-07 |  | 2024-08-27 | 2025-03-07 | 115d | 2024-08-06 | 2025-01-13 | 0d |  |  | N/A | N/A | 5.28 | N/A | Qualification |  |  |  |  |  |  |  |
| 1446 | 1.4.3.3.3.9.1 | Coordinate Qualification Participants' environment preparation |  | 20d | 2024-11-18 | 2024-12-13 |  | 2024-11-18 | 2024-12-13 | 60d | 2024-08-06 | 2024-10-28 | 789d |  | start no earlier than 2024-11-18 | SI Test | Code Bodies, PP | 5.28 | Simon Berry | Qualification | 31.33 | Green | GREEN |  |  |  |  |
| 1447 | 1.4.3.3.3.9.2 | Coordinate deployment of MHHS solution code to Qualification Participants' UIT environments |  | 20d | 2024-12-16 | 2025-01-10 |  | 2024-12-16 | 2025-01-10 | 10d | 2024-10-15 | 2024-10-28 | 729d | 0d | start no earlier than 2024-12-16 | SI Test | Code Bodies, PP | 5.28 | Simon Berry | Qualification | 59.33 | Green | GREEN |  |  |  |  |
| 1448 | 1.4.3.3.3.9.3 | Qualification Testing Wave 2 Participants' UIT environments ready to start connectivity proving (incl. certificates and security compliance) |  | 15d | 2025-01-13 | 2025-01-31 | 1447 | 2025-01-13 | 2025-01-31 | 0d | 2024-11-04 | 2024-11-04 | 729d | 0d |  | SI Test | Code Bodies, PP, IPA | 5.28 | Simon Berry | Qualification | 87.33 | Green | GREEN | MHHS-ART073 | New? | QAG | T3 |
| 1449 | 1.4.3.3.3.9.4 | **Coordinate Qualification Participants' connectivity proving (S&A)** |  | 25d | 2024-08-27 | 2024-09-30 |  | 2024-08-27 | 2024-09-30 | 50d | 2024-11-05 | 2025-01-13 |  |  |  | N/A | N/A | 5.0 | N/A | Qualification |  |  |  |  |  |  |  |
| 1450 | 1.4.3.3.3.9.4.1 | Assurance of Qualification Participants' connectivity proving |  | 25d | 2025-02-03 | 2025-03-07 | 1448 | 2025-02-03 | 2025-03-07 | 50d | 2024-11-05 | 2025-01-13 | 729d |  |  | SI Test | Code Bodies, PP | 5.0 |  | Qualification | 108.33 | Green | GREEN |  |  |  |  |
| 1451 | 1.4.3.3.3.10 | **Environments (S&A) Wave 3** |  | 80d | 2025-03-17 | 2025-07-04 |  | 2025-03-17 | 2025-07-04 | 115d | 2024-08-06 | 2025-01-13 | 644d |  |  | N/A | N/A | 5.28 | N/A | Qualification |  |  |  |  |  |  |  |
| 1452 | 1.4.3.3.3.10.1 | Coordinate Qualification Participants' environment preparation |  | 30d | 2025-03-17 | 2025-04-25 |  | 2025-03-17 | 2025-04-25 | 60d | 2024-08-06 | 2024-10-28 | 694d |  | start no earlier than 2025-03-17 | SI Test | Code Bodies, PP | 5.28 | Simon Berry | Qualification | 150.33 | Green | GREEN |  |  |  |  |
| 1453 | 1.4.3.3.3.10.2 | Coordinate deployment of MHHS solution code to Qualification Participants' UIT environments |  | 10d | 2025-04-28 | 2025-05-09 |  | 2025-04-28 | 2025-05-09 | 10d | 2024-10-15 | 2024-10-28 | 644d | 0d | start no earlier than 2025-04-28 | SI Test | Code Bodies, PP | 5.28 | Simon Berry | Qualification | 192.33 | Green | GREEN |  |  |  |  |
| 1454 | 1.4.3.3.3.10.3 | Qualification Testing Wave 3 Participants' UIT environments ready to start connectivity proving (incl. certificates and security compliance) |  | 14d | 2025-05-13 | 2025-05-30 | 1453FS+1d | 2025-05-13 | 2025-05-30 | 0d | 2024-11-04 | 2024-11-04 | 644d | 0d |  | SI Test | Code Bodies, PP, IPA | 5.28 | Simon Berry | Qualification | 207.33 | Green | GREEN | MHHS-ART073 | New? | QAG | T3 |
| 1455 | 1.4.3.3.3.10.4 | **Coordinate Qualification Participants' connectivity proving (S&A)** |  | 25d | 2025-06-02 | 2025-07-04 |  | 2025-06-02 | 2025-07-04 | 50d | 2024-11-05 | 2025-01-13 | 644d |  |  | N/A | N/A | 5.0 | N/A | Qualification |  |  |  |  |  |  |  |
| 1456 | 1.4.3.3.3.10.4.1 | Assurance of Qualification Participants' connectivity proving |  | 25d | 2025-06-02 | 2025-07-04 | 1454 | 2025-06-02 | 2025-07-04 | 50d | 2024-11-05 | 2025-01-13 | 644d |  |  | SI Test | Code Bodies, PP | 5.0 |  | Qualification | 227.33 | Green | GREEN |  |  |  |  |

Notes:
- 1433: 8/7/24: Updated to reflect the separation between non-sit and s and a and the 4 waves for s and a
- 1434: 8/7/24: Updated to reflect the separation between non-sit and s and a and the 4 waves for s and a
- 1435: 8/7/24: Updated to reflect the separation between non-sit and s and a and the 4 waves for s and a
- 1436: 8/7/24: Updated to reflect the separation between non-sit and s and a and the 4 waves for s and a
- 1439: 8/7/24: Updated to reflect the separation between non-sit and s and a and the 4 waves for s and a
- 1440: 8/7/24: Updated to reflect the separation between non-sit and s and a and the 4 waves for s and a
- 1441: 8/7/24: Updated to reflect the separation between non-sit and s and a and the 4 waves for s and a
- 1442: 8/7/24: Updated to reflect the separation between non-sit and s and a and the 4 waves for s and a
- 1445: 8/7/24: Updated to reflect the separation between non-sit and s and a and the 4 waves for s and a
- 1446: 8/7/24: Updated to reflect the separation between non-sit and s and a and the 4 waves for s and a
- 1447: 8/7/24: Updated to reflect the separation between non-sit and s and a and the 4 waves for s and a
- 1448: 8/7/24: Updated to reflect the separation between non-sit and s and a and the 4 waves for s and a
- 1451: 8/7/24: Updated to reflect the separation between non-sit and s and a and the 4 waves for s and a
- 1452: 8/7/24: Updated to reflect the separation between non-sit and s and a and the 4 waves for s and a
- 1453: 8/7/24: Updated to reflect the separation between non-sit and s and a and the 4 waves for s and a
- 1454: 8/7/24: Updated to reflect the separation between non-sit and s and a and the 4 waves for s and a

| ID | WBS | Task | Duration | Start | Finish | Predecessors | Complete | Remaining | Baseline start | Baseline finish | Baseline duration | Baseline 1 start | Baseline 1 finish | Total slack | Free slack | Constraint | Baseline cost | Responsible | Involved | Update Version | MHHS Resource Name | MHHS Programme Phase | Task Status | Sched Status | RAG | Artefact ID | Milestone ID | Text29 | Tier |
| --- | --- | --- | --- | --- | --- | --- | --- | --- | --- | --- | --- | --- | --- | --- | --- | --- | --- | --- | --- | --- | --- | --- | --- | --- | --- | --- | --- | --- | --- |
| 1457 | 1.4.3.3.3.11 | **Environments (S&A) Wave 4** | 80d | 2025-03-17 | 2025-07-04 |  |  |  | 2025-03-17 | 2025-07-04 | 115d | 2024-08-06 | 2025-01-13 | 55d |  |  |  | N/A | N/A | 5.28 | N/A | Qualification |  |  |  |  |  |  |  |
| 1458 | 1.4.3.3.3.11.1 | Coordinate Qualification Participants' environment preparation | 30d | 2025-03-17 | 2025-04-25 |  |  |  | 2025-03-17 | 2025-04-25 | 60d | 2024-08-06 | 2024-10-28 | 694d |  | finish no earlier than 2025-04-25 |  | SI Test | Code Bodies, PP | 5.28 | Simon Berry | Qualification | 150.33 | Green | GREEN |  |  |  |  |
| 1459 | 1.4.3.3.3.11.2 | Coordinate deployment of MHHS solution code to Qualification Participants' UIT environments | 10d | 2025-04-28 | 2025-05-09 |  |  |  | 2025-04-28 | 2025-05-09 | 10d | 2024-10-15 | 2024-10-28 | 644d | 0d | finish no earlier than 2025-05-09 |  | SI Test | Code Bodies, PP | 5.28 | Simon Berry | Qualification | 192.33 | Green | GREEN |  |  |  |  |
| 1460 | 1.4.3.3.3.11.3 | Qualification Testing Wave 4 Participants' UIT environments ready to start connectivity proving (incl. certificates and security compliance) | 14d | 2025-05-13 | 2025-05-30 | 1459FS+1d |  |  | 2025-05-13 | 2025-05-30 | 0d | 2024-11-04 | 2024-11-04 | 644d | 0d | finish no earlier than 2025-05-30 |  | SI Test | Code Bodies, PP, IPA | 5.28 | Simon Berry | Qualification | 207.33 | Green | GREEN | MHHS-ART073 | New? | QAG | T3 |
| 1461 | 1.4.3.3.3.11.4 | **Coordinate Qualification Participants' connectivity proving (S&A)** | 25d | 2025-06-02 | 2025-07-04 |  |  |  | 2025-06-02 | 2025-07-04 | 50d | 2024-11-05 | 2025-01-13 |  |  |  |  | N/A | N/A | 5.0 | N/A | Qualification |  |  |  |  |  |  |  |
| 1462 | 1.4.3.3.3.11.4.1 | Assurance of Qualification Participants' connectivity proving | 25d | 2025-06-02 | 2025-07-04 | 1460 |  |  | 2025-06-02 | 2025-07-04 | 50d | 2024-11-05 | 2025-01-13 | 644d |  | start no earlier than 2025-06-02 |  | SI Test | Code Bodies, PP | 5.0 |  | Qualification | 227.33 | Green | GREEN |  |  |  |  |
| 1463 | 1.4.3.4 | **Test Data** | 30d | 2024-08-26 | 2024-10-04 |  |  |  | 2024-08-26 | 2024-10-04 | 30d | 2024-08-26 | 2024-10-04 | 819d |  |  | -0 | N/A | N/A | 5.0 | N/A | Systems Integration Testing (SIT) |  |  |  |  |  |  |  |
| 1464 | 1.4.3.4.1 | **Central Parties (for E2E Sandbox & Qualification)** | 30d | 2024-08-26 | 2024-10-04 |  |  |  | 2024-08-26 | 2024-10-04 | 30d | 2024-08-26 | 2024-10-04 | 819d |  |  |  | N/A | N/A | 5.0 | N/A | Systems Integration Testing (SIT) |  |  |  |  |  |  |  |
| 1465 | 1.4.3.4.1.1 | Central Parties' UIT environment test data loading & verification (& data cleansing, if required) | 30d | 2024-08-26 | 2024-10-04 |  |  |  | 2024-08-26 | 2024-10-04 | 30d | 2024-08-26 | 2024-10-04 | 819d | 0d | start no earlier than 2024-08-26 |  | PP | SI Test | 5.0 | Richard Puddephatt | Systems Integration Testing (SIT) | -52.67 | Green | GREEN |  |  |  |  |
| 1466 | 1.4.3.4.1.2 | Submit self-declaration to Programme to confirm loading & verification of test data | 30d | 2024-08-26 | 2024-10-04 | 1465SS |  |  | 2024-08-26 | 2024-10-04 | 30d | 2024-08-26 | 2024-10-04 | 819d | 0d |  |  | PP | SI Test | 5.0 | Richard Puddephatt | Systems Integration Testing (SIT) | -52.67 | Green | GREEN |  |  |  |  |
| 1467 | 1.4.3.4.2 | **E2E Sandbox Participants** | 30d | 2024-08-26 | 2024-10-04 |  |  |  | 2024-08-26 | 2024-10-04 | 30d | 2024-08-26 | 2024-10-04 | 839d |  |  | -0 | N/A | N/A | 5.0 | N/A | Systems Integration Testing (SIT) |  |  |  |  |  |  |  |
| 1468 | 1.4.3.4.2.1 | UIT environment test data loading and verification (and data cleansing, if required) (for E2E Sandbox Testing Start) | 30d | 2024-08-26 | 2024-10-04 | 1465FF |  |  | 2024-08-26 | 2024-10-04 | 30d | 2024-08-26 | 2024-10-04 | 839d | 0d |  |  | PP | SI Test | 5.0 | Richard Puddephatt | Systems Integration Testing (SIT) | -52.67 | Green | GREEN |  |  |  |  |
| 1469 | 1.4.3.4.3 | **SI Test Data** | 30d | 2024-08-26 | 2024-10-04 |  |  |  | 2024-08-26 | 2024-10-04 | 30d | 2024-08-26 | 2024-10-04 | 839d |  |  |  | N/A | N/A | 5.0 | N/A | Systems Integration Testing (SIT) |  |  |  |  |  |  |  |
| 1470 | 1.4.3.4.3.1 | Coordinate Central Parties' UIT environment test data loading and verification (and data cleansing, if required) | 30d | 2024-08-26 | 2024-10-04 | 1465SS |  |  | 2024-08-26 | 2024-10-04 | 30d | 2024-08-26 | 2024-10-04 | 839d |  |  |  | SI Test | PP | 5.0 | Richard Puddephatt | Systems Integration Testing (SIT) | -52.67 | Green | GREEN |  |  |  |  |
| 1471 | 1.4.3.4.3.2 | Assure evidence of Central Parties' UIT environment test data load and verification | 30d | 2024-08-26 | 2024-10-04 | 1466SS |  |  | 2024-08-26 | 2024-10-04 | 30d | 2024-08-26 | 2024-10-04 | 839d |  |  |  | SI Test | PP | 5.0 | Richard Puddephatt | Systems Integration Testing (SIT) | -52.67 | Green | GREEN |  |  |  |  |
| 1472 | 1.4.3.4.3.3 | Coordinate E2E Sandbox Participants' UIT environment test data loading and verification (and data cleansing, if required) (for E2E Sandbox Testing Start) | 30d | 2024-08-26 | 2024-10-04 | 1468SS |  |  | 2024-08-26 | 2024-10-04 | 30d | 2024-08-26 | 2024-10-04 | 839d |  |  |  | SI Test | PP | 5.0 | Richard Puddephatt | Systems Integration Testing (SIT) | -52.67 | Green | GREEN |  |  |  |  |
| 1473 | 1.4.3.5 | **Other Preparation** | 496d | 2022-10-31 A | 2024-09-23 |  | 59% | 201.3d | 2022-10-31 | 2024-09-23 | 484d | 2022-11-16 | 2024-09-23 | 848d |  |  |  | N/A | N/A | 5.0 | N/A | Systems Integration Testing (SIT) |  |  |  |  |  |  |  |
| 1474 | 1.4.3.5.1 | **SI Other Preparation** | 66d | 2022-10-31 | 2023-01-30 |  |  |  | 2022-10-31 | 2023-01-30 | 66d | 2024-05-02 | 2024-08-01 | 1278d |  |  |  | N/A | N/A | 5.0 | N/A | Systems Integration Testing (SIT) |  |  |  |  |  |  |  |
| 1475 | 1.4.3.5.1.1 | Onboarding of UIT E2E Sandbox Participants to Test Management Tool for E2E Sandbox Testing Start (onboarding of participants will be ongoing hereafter) | 66d | 2022-10-31 | 2023-01-30 |  |  |  | 2022-10-31 | 2023-01-30 | 66d | 2024-05-02 | 2024-08-01 | 1278d | 393d |  |  | SI Test | PP | 5.0 | Stuart Scott | Systems Integration Testing (SIT) | -717.67 | Overdue Start | RED |  |  |  |  |
| 1476 | 1.4.3.5.2 | **Other Preparation (for Central Parties & E2E Sandbox Participants)** | 484d | 2022-11-16 A | 2024-09-23 |  | 67% | 161.92d | 2022-11-16 | 2024-09-23 | 484d | 2022-11-16 | 2024-09-23 | 848d |  |  |  | N/A | N/A | 5.0 | N/A | Systems Integration Testing (SIT) |  |  |  |  |  |  |  |
| 1477 | 1.4.3.5.2.1 | Test Management Tool onboarding for E2E Sandbox Testing Start (onboarding will be ongoing hereafter) | 66d | 2024-05-02 | 2024-08-01 | 1475SS |  |  | 2024-05-02 | 2024-08-01 | 66d | 2024-05-02 | 2024-08-01 | 885d |  | start no earlier than 2024-05-02 |  | PP | SI Test | 5.0 | Stuart Scott | Systems Integration Testing (SIT) | -168.67 | Overdue Start | RED |  |  |  |  |
| 1478 | 1.4.3.5.2.2 | Other Preparation (incl. test execution planning) | 484d | 2022-11-16 A | 2024-09-23 | 1415SS, 1421SS | 76% | 118d | 2022-11-16 | 2024-09-23 | 484d | 2022-11-16 | 2024-09-23 | 848d |  |  |  | PP | SI Test | 5.0 | Stuart Scott | Systems Integration Testing (SIT) |  | Green | GREEN |  |  |  |  |
| 1479 | 1.4.3.6 | **UIT E2E Sandbox Test Readiness Report** | 114d | 2024-08-26 | 2025-01-31 |  |  |  | 2024-08-26 | 2025-01-31 | 114d | 2024-08-26 | 2024-10-25 | 750d |  |  | -0 | N/A | N/A | 5.0 | N/A | Systems Integration Testing (SIT) |  |  |  |  |  |  |  |
| 1480 | 1.4.3.6.1 | **Central Parties E2E Sandbox Test Readiness Report** | 30d | 2024-08-26 | 2024-10-04 |  |  |  | 2024-08-26 | 2024-10-04 | 30d | 2024-08-26 | 2024-10-04 | 819d |  |  |  | N/A | N/A | 5.0 | N/A | Systems Integration Testing (SIT) |  |  |  |  |  |  |  |
| 1481 | 1.4.3.6.1.1 | Develop draft Test Readiness Report and submit to Programme for assurance | 20d | 2024-08-26 | 2024-09-20 | 1466FF-10d |  |  | 2024-08-26 | 2024-09-20 | 20d | 2024-08-26 | 2024-09-20 | 819d | 0d |  |  | PP | SI Test | 5.0 | Stuart Scott | Systems Integration Testing (SIT) | -52.67 | Green | GREEN |  |  |  |  |
| 1482 | 1.4.3.6.1.2 | Finalise Test Readiness Report and submit to Programme for assurance | 10d | 2024-09-23 | 2024-10-04 | 1466FF |  |  | 2024-09-23 | 2024-10-04 | 10d | 2024-09-23 | 2024-10-04 | 819d | 0d |  |  | PP | SI Test | 5.0 | Stuart Scott | Systems Integration Testing (SIT) | -24.67 | Green | GREEN |  |  |  |  |

Notes:
- 1457: 8/7/24: Updated to reflect the separation between non-sit and s and a and the 4 waves for s and a
- 1458: 8/7/24: Updated to reflect the separation between non-sit and s and a and the 4 waves for s and a
- 1459: 8/7/24: Updated to reflect the separation between non-sit and s and a and the 4 waves for s and a
- 1460: 8/7/24: Updated to reflect the separation between non-sit and s and a and the 4 waves for s and a
- 1465: 1/5: changed from Simon berry to richard puddephatt. Link was 1143(5579) doesnt work now as the date has changed
- 1466: 1/5: changed from Simon berry to richard puddephatt
- 1468: 1/5: changed from Simon berry to richard puddephatt

| ID | WBS | Task | Type | Duration | Start | Finish | Predecessors | Complete | Remaining | Baseline start | Baseline finish | Baseline duration | Baseline 1 start | Baseline 1 finish | Total slack | Free slack | Constraint | Baseline cost | Responsible | Involved | Update Version | MHHS Resource Name | MHHS Programme Phase | Task Status | Sched Status | RAG | Artefact ID | Milestone ID | Text29 | Tier | Text3 |
| --- | --- | --- | --- | --- | --- | --- | --- | --- | --- | --- | --- | --- | --- | --- | --- | --- | --- | --- | --- | --- | --- | --- | --- | --- | --- | --- | --- | --- | --- | --- | --- |
| 1483 | 1.4.3.6.2 | **SI E2E Sandbox Test Readiness Report** |  | 40d | 2024-08-26 | 2024-10-18 |  |  |  | 2024-08-26 | 2024-10-18 | 40d | 2024-08-26 | 2024-10-18 | 819d |  |  |  | N/A | N/A | 5.0 | N/A | Systems Integration Testing (SIT) |  |  |  |  |  |  |  |  |
| 1484 | 1.4.3.6.2.1 | Assure Central Parties' E2E Sandbox Test Readiness Reports |  | 35d | 2024-08-26 | 2024-10-11 | 1481SS, 1482FF+5d |  |  | 2024-08-26 | 2024-10-11 | 35d | 2024-08-26 | 2024-10-11 | 819d | 0d |  |  | SI Test | PP | 5.0 | Stuart Scott | Systems Integration Testing (SIT) | -52.67 | Green | GREEN |  |  |  |  |  |
| 1485 | 1.4.3.6.2.2 | Develop Overarching E2E Sandbox Test Readiness Report |  | 20d | 2024-09-16 | 2024-10-11 | 1484FF |  |  | 2024-09-16 | 2024-10-11 | 20d | 2024-09-16 | 2024-10-11 | 819d | 0d |  |  | SI Test |  | 5.0 | Stuart Scott | Systems Integration Testing (SIT) | -31.67 | Green | GREEN |  |  |  |  |  |
| 1486 | 1.4.3.6.2.3 | Artefact review (via SITAG) and updates |  | 5d | 2024-10-14 | 2024-10-18 | 1485 |  |  | 2024-10-14 | 2024-10-18 | 5d | 2024-10-14 | 2024-10-18 | 819d | 69d |  |  | SI Test | PP,IPA | 5.0 | Stuart Scott | Systems Integration Testing (SIT) | -3.67 | Green | GREEN |  |  |  |  |  |
| 1487 | 1.4.3.6.3 | UIT E2E Sandbox Preparation Complete | milestone | 0d | 2025-01-31 | 2025-01-31 | 1486FS+5d |  |  | 2025-01-31 | 2025-01-31 | 0d | 2024-10-25 | 2024-10-25 | 750d | 1d | start no earlier than 2025-01-31 |  | SI Test | PP | 5.28 | Stuart Scott | Systems Integration Testing (SIT) | 105.33 | Green | GREEN | MHHS-ART154 MHHS-ART147 | T3-TE-0048 | QAG | T3 |  |
| 1488 | 1.4.4 | **SIT PPs Early Sandbox Testing Execution** |  | 316d | 2025-02-07 | 2026-04-24 |  |  |  | 2025-02-07 | 2026-04-24 | 316d | 2024-11-04 | 2026-01-19 | 434d |  |  | -0 | N/A | N/A | 5.0 | N/A | Systems Integration Testing (SIT) |  |  |  |  |  |  |  |  |
| 1489 | 1.4.4.1 | SIT PPs E2E Sandbox Testing Start | milestone | 0d | 2025-02-10 | 2025-02-10 | 1487FS+5d |  |  | 2025-02-10 | 2025-02-10 | 0d | 2024-11-04 | 2024-11-04 | 749d | 0d | start no earlier than 2025-02-10 |  | SI Test | PP | 5.28 | Stuart Scott | Systems Integration Testing (SIT) | 115.33 | Green | GREEN | MHHS-ART018 MHHS-ART154 MHHS-ART147 | T3-TE-0049 | QAG | T3 |  |
| 1490 | 1.4.4.2 | SIT PPs E2E Sandbox Testing Execution |  | 316d | 2025-02-07 | 2026-04-24 | 1489SS-1d |  |  | 2025-02-07 | 2026-04-24 | 316d | 2024-11-04 | 2026-01-19 | 434d |  | start no earlier than 2024-11-04 |  | PP | SI Test | 5.0 | Stuart Scott | Systems Integration Testing (SIT) | 112.33 | Green | GREEN |  |  |  |  |  |
| 1491 | 1.4.5 | **System Integration Testing - Tier 1 Milestones** |  | 214d? | 2025-02-28 | 2025-12-24 |  |  |  | 2025-02-28 | 2025-12-24 | 0d |  |  | 154d |  |  |  |  |  |  |  |  | -685.67 | Overdue Start | RED |  |  |  |  |  |
| 1492 | 1.4.5.1 | M10 Checkpoint |  | 1d? | 2025-02-28 | 2025-02-28 | 1493FS-149d |  |  | 2025-02-28 | 2025-02-28 |  |  |  | 734d |  |  |  |  |  | 6.1 |  |  | 133.33 | Green | GREEN |  | T3-MI-0040 |  |  |  |
| 1493 | 1.4.5.2 | Central systems ready for migrating MPANs (M10) | milestone | 0d | 2025-09-24 | 2025-09-24 | 1356FS+20d, 2539, 2296FS+2d, 2293, 2308, 2295, 2275, 2279 |  |  | 2025-09-24 | 2025-09-24 | 0d | 2025-03-07 | 2025-03-07 | 5d | 0d | start no earlier than 2025-08-13 |  | CPT | CPT | 6.1 | CPT | Migration | 341.71 | Green | RED |  | T1-MI-1000 | PSG | T1 | Central systems ready for migrating MPANs |
| 1494 | 1.4.5.3 | Central systems ready for migrating MPANs (M10*) - Late Exit | milestone | 0d | 2025-12-24 | 2025-12-24 | 1493FS+65d |  |  | 2025-12-24 | 2025-12-24 | 0d | 2025-06-06 | 2025-06-06 | 521d |  |  |  | CPT | CPT | 5.0 | CPT | Migration | 432.71 | Green | GREEN |  | T2-MI-1500 | PSG | T1 | Central systems ready for migrating MPANs |
| 1495 | 1.4.6 | **External Programme Dependency Management** |  | 174d | 2022-10-31 A | 2023-06-30 A |  | 100% |  | 2022-10-31 | 2023-06-30 | 174d | 2022-10-31 | 2023-06-30 |  |  |  |  | N/A | N/A | 5.0 | N/A | Systems Integration Testing (SIT) |  |  |  |  |  |  |  |  |
| 1496 | 1.4.6.1 | **BSC CP1558** |  | 173d | 2022-10-31 A | 2023-06-29 A |  | 100% |  | 2022-10-31 | 2023-06-29 | 173d | 2022-10-31 | 2023-06-29 |  |  |  |  | N/A | N/A | 5.0 | N/A | Systems Integration Testing (SIT) |  |  |  |  |  |  |  |  |
| 1497 | 1.4.6.1.1 | Monitor progress to implementation date |  | 173d | 2022-10-31 A | 2023-06-28 A |  | 100% |  | 2022-10-31 | 2023-06-28 | 173d | 2022-10-31 | 2023-06-28 |  |  |  |  | CPT | Code Bodies | 5.0 | Andrew Margan | Systems Integration Testing (SIT) |  | Complete | COMPLETE |  |  |  |  |  |
| 1498 | 1.4.6.1.2 | BSC CP1558 Implementation Date | milestone | 0d | 2023-06-29 A | 2023-06-29 A | 1497 | 100% |  | 2023-06-29 | 2023-06-29 | 0d | 2023-06-29 | 2023-06-29 |  |  | must start on 2023-06-29 |  | Code Bodies |  | 5.0 | Andrew Margan | Systems Integration Testing (SIT) |  | Complete | COMPLETE |  |  |  |  |  |
| 1499 | 1.4.6.2 | **REC CP R0032** |  | 174d | 2022-10-31 A | 2023-06-30 A |  | 100% |  | 2022-10-31 | 2023-06-30 | 174d | 2022-10-31 | 2023-06-30 |  |  |  |  | N/A | N/A | 5.0 | N/A | Systems Integration Testing (SIT) |  |  |  |  |  |  |  |  |
| 1500 | 1.4.6.2.1 | Monitor progress to implementation date |  | 174d | 2022-10-31 A | 2023-06-29 A |  | 100% |  | 2022-10-31 | 2023-06-29 | 174d | 2022-10-31 | 2023-06-29 |  |  |  |  | CPT | Code Bodies | 5.0 | Andrew Margan | Systems Integration Testing (SIT) |  | Complete | COMPLETE |  |  |  |  |  |
| 1501 | 1.4.6.2.2 | REC CP R0032 Implementation Date | milestone | 0d | 2023-06-30 A | 2023-06-30 A | 1500 | 100% |  | 2023-06-30 | 2023-06-30 | 0d | 2023-06-30 | 2023-06-30 |  |  | must start on 2023-06-30 |  | Code Bodies |  | 5.0 | Andrew Margan | Systems Integration Testing (SIT) |  | Complete | COMPLETE |  |  |  |  |  |
| 1502 | 1.4.6.3 | **REC CP R0044** |  | 173d | 2022-10-31 A | 2023-06-29 A |  | 100% |  | 2022-10-31 | 2023-06-29 | 173d | 2022-10-31 | 2023-06-29 |  |  |  |  | N/A | N/A | 5.0 | N/A | Systems Integration Testing (SIT) |  |  |  |  |  |  |  |  |
| 1503 | 1.4.6.3.1 | Monitor progress to implementation date |  | 173d | 2022-10-31 A | 2023-06-28 A |  | 100% |  | 2022-10-31 | 2023-06-28 | 173d | 2022-10-31 | 2023-06-28 |  |  |  |  | CPT | Code Bodies | 5.0 | Andrew Margan | Systems Integration Testing (SIT) |  | Complete | COMPLETE |  |  |  |  |  |
| 1504 | 1.4.6.3.2 | REC CP R0044 Implementation Date | milestone | 0d | 2023-06-29 A | 2023-06-29 A | 1503 | 100% |  | 2023-06-29 | 2023-06-29 | 0d | 2023-06-29 | 2023-06-29 |  |  | must start on 2023-06-29 |  | Code Bodies |  | 5.0 | Andrew Margan | Systems Integration Testing (SIT) |  | Complete | COMPLETE |  |  |  |  |  |
| 1505 | 1.5 | **NON SIT LDSO QUALIFICATION** |  | 469d? | 2023-11-07 A | 2025-08-22 |  | 67% | 155.25d? | 2023-11-07 | 2025-08-22 | 343d | 2024-01-29 | 2024-07-05 | 609d |  |  | -0 | N/A | N/A |  | N/A | Systems Integration Testing (SIT) |  |  |  |  |  |  |  |  |
| 1506 | 1.5.1 | **Approach Planning** |  | 208d | 2023-11-07 A | 2024-08-22 A |  | 100% |  | 2023-11-07 | 2024-08-22 | 208d |  |  |  |  |  | -0 | N/A | N/A | 5.24 | N/A |  | -386.67 |  |  |  |  |  |  |  |
| 1507 | 1.5.1.1 | Develop Draft Testing Approach & Plan |  | 61d | 2023-11-07 A | 2024-01-30 A |  | 100% |  | 2023-11-07 | 2024-01-30 | 61d |  |  |  |  | start no earlier than 2023-11-07 |  | Non-SIT LDSO | Non-SIT LDSO | 5.24 | Ben Wickins |  |  | Complete | COMPLETE |  |  |  |  |  |
| 1508 | 1.5.1.2 | Draft Testing Approach & Plan Issued to LDSO for Review |  | 1d | 2024-01-31 A | 2024-01-31 A | 1507 | 100% |  | 2024-01-31 | 2024-01-31 | 1d |  |  |  |  |  |  | Non-SIT LDSO | Non-SIT LDSO | 5.24 | Ben Wickins |  |  | Complete | COMPLETE |  |  |  |  |  |
| 1509 | 1.5.1.3 | LDSO Review Complete |  | 10d | 2024-02-01 A | 2024-02-14 A | 1508 | 100% |  | 2024-02-01 | 2024-02-14 | 10d |  |  |  |  |  |  | LDSOs | Non-SIT LDSO | 5.24 | Ben Wickins |  |  | Complete | COMPLETE |  |  |  |  |  |
| 1510 | 1.5.1.4 | Update Following LDSO Review |  | 14d | 2024-02-15 A | 2024-03-05 A | 1509 | 100% |  | 2024-02-15 | 2024-03-05 | 14d |  |  |  |  |  |  | Non-SIT LDSO | Non-SIT LDSO, Code Bodies | 5.24 | Ben Wickins |  |  | Complete | COMPLETE |  |  |  |  |  |
| 1511 | 1.5.1.5 | QWG Review of Approach & Plan |  | 1d | 2024-03-12 A | 2024-03-12 A | 1510FS+4d | 100% |  | 2024-03-12 | 2024-03-12 | 1d |  |  |  |  |  |  | Non-SIT LDSO, PP | Non-SIT LDSO, Code Bodies | 5.24 | Ben Wickins |  |  | Complete | COMPLETE |  |  |  |  |  |
| 1512 | 1.5.1.6 | QAG Approval for Approach & Plan | milestone | 0d | 2024-03-21 A | 2024-03-21 A | 1511FS+7d | 100% |  | 2024-03-21 | 2024-03-21 | 0d |  |  |  |  |  |  | Code Bodies | Non-SIT LDSO,Code Bodies | 5.24 | Ben Wickins |  |  | Complete | COMPLETE |  |  |  |  |  |
| 1513 | 1.5.1.7 | Confirmation of Participants for Non-SIT LDSO Qualification Testing | milestone | 0d | 2024-03-21 A | 2024-03-21 A | 1512 | 100% |  | 2024-03-21 | 2024-03-21 | 0d | 2024-01-29 | 2024-01-29 |  |  |  |  | Non-SIT LDSO | SI Test, PP, IPA | 5.24 | Ben Wickins | Systems Integration Testing (SIT) |  | Complete | COMPLETE |  | T3-QU-0011 | QAG (Non-SIT LDSO) | T3 |  |
| 1514 | 1.5.1.8 | Update to Annex 1 for internal review (NF, Not Operational) |  | 15d | 2024-03-18 A | 2024-04-05 A | 1017 | 100% |  | 2024-03-18 | 2024-04-05 | 15d |  |  |  |  |  |  | Non-SIT LDSO | PP, Code Bodies | 5.24 | Ben Wickins |  |  | Complete | COMPLETE |  |  |  |  |  |
| 1515 | 1.5.1.9 | Non-Functional, Operational & Migration Approaches Socialised with Code Bodies & LDSO & Feedback Actioned |  | 86d | 2024-04-08 A | 2024-08-05 A | 1514 | 100% |  | 2024-04-08 | 2024-08-05 | 86d |  |  |  |  |  |  | Non-SIT LDSO | PP, Code Bodies | 5.27 | Ben Wickins |  |  | Complete | COMPLETE |  |  |  |  |  |
| 1516 | 1.5.1.10 | QWG Review Operational, Non-Functional & Migration Annexes of Approach & Plan |  | 1d | 2024-08-13 A | 2024-08-13 A | 1515FS+5d | 100% |  | 2024-08-13 | 2024-08-13 | 1d |  |  |  |  |  |  | Non-SIT LDSO, PP | Non-SIT LDSO, PP, Code Bodies | 5.27 | Ben Wickins |  |  | Complete | COMPLETE |  |  |  |  |  |
| 1517 | 1.5.1.11 | Update Following QWG Review |  | 6d | 2024-08-14 A | 2024-08-21 A | 1516 | 100% |  | 2024-08-14 | 2024-08-21 | 6d |  |  |  |  |  |  | Non-SIT LDSO, PP | Non-SIT LDSO, Code Bodies | 5.27 | Ben Wickins |  |  | Complete | COMPLETE |  |  |  |  |  |
| 1518 | 1.5.1.12 | QAG Approval for Operational, Non-Functional & Migration Annexes of Approach & Plan | milestone | 0d | 2024-08-22 A | 2024-08-22 A | 1517FS+1d, 1513, 1020 | 100% |  | 2024-08-22 | 2024-08-22 | 0d |  |  |  |  |  |  | Code Bodies | Non-SIT LDSO, Code Bodies | 5.29 | Ben Wickins |  |  | Complete | COMPLETE |  | T3-QU-0110 | QAG (Non-SIT LDSO) |  |  |

Notes:
- 1487: 11/7/24: Date change approved at QAG on 20/6/24 from 25/10/24 to 31/1/25
- 1489: 11/7/24: Date change approved at QAG on 20/6/24 from 4/11/24 to 10/2/25
- 1493: 16/09/24 - Date updated to 13/08/25 in line with recalibration exercise.
- 1513: Have confirmed LDSOs going through SIT. We should receive notifications on non-SIT through January. Milestone holds to baseline. 13/5: date on cr47 was 18/4 but completed before CR approved
- 1514: Includes time to update Approach & Plan with updates / Guidance: 26/3: Linked to the development of SIT non functional plan
- 1518: Date missed because the Non-Functional Test Materials are not available for the July QAG and therefore to maintain our approach of approving plans in parallel with materials, the date has moved to the August QAG. There is no impact on the deliverability / Guidance: 18/7/24: Date change from 18/7/24 to 22/8/24 approved at QAG on 18/7/24 / Notes (2): of the overall project. Project to engage with Code Bodies and industry in sufficient time to review all required materials. To go to July QAG for baseline date change

| ID | WBS | Task | Type | Duration | Start | Finish | Predecessors | Complete | Remaining | Baseline start | Baseline finish | Baseline duration | Baseline 1 start | Baseline 1 finish | Total slack | Constraint | Baseline cost | Responsible | Involved | Task Status | Update Version | MHHS Resource Name | Sched Status | RAG | Milestone ID | Text29 | MHHS Programme Phase | Tier |
| --- | --- | --- | --- | --- | --- | --- | --- | --- | --- | --- | --- | --- | --- | --- | --- | --- | --- | --- | --- | --- | --- | --- | --- | --- | --- | --- | --- | --- |
| 1519 | 1.5.2 | **Functional Test Cases & Scenarios** |  | 58d | 2024-01-30 A | 2024-04-18 A |  | 100% |  | 2024-01-30 | 2024-04-18 | 58d |  |  |  |  | -0 | N/A | N/A | -385.67 | 5.24 | N/A |  |  |  |  |  |  |
| 1520 | 1.5.2.1 | **Functional Test Cases & Scenarios Batch 1** |  | 8d | 2024-01-30 A | 2024-02-08 A |  | 100% |  | 2024-01-30 | 2024-02-08 | 8d |  |  |  |  | -0 | N/A | N/A |  | 5.24 | N/A |  |  |  |  |  |  |
| 1521 | 1.5.2.1.1 | Walkthrough Test Cases & Scenarios Batch 1 with Code Bodies |  | 1d | 2024-01-30 A | 2024-01-30 A | 1507SS+60d | 100% |  | 2024-01-30 | 2024-01-30 | 1d |  |  |  |  |  | Non-SIT LDSO | Non-SIT LDSO, Code Bodies |  | 5.24 | Ben Wickins | Complete | COMPLETE |  |  |  |  |
| 1522 | 1.5.2.1.2 | Walkthrough Test Cases & Scenarios Batch 1 with LDSO |  | 1d | 2024-02-01 A | 2024-02-01 A | 1521 | 100% |  | 2024-02-01 | 2024-02-01 | 1d |  |  |  |  |  | LDSO, Non-SIT LDSO | LDSO, Non-SIT LDSO |  | 5.24 | Ben Wickins | Complete | COMPLETE |  |  |  |  |
| 1523 | 1.5.2.1.3 | Action Feedback on Test Cases & Scenarios Batch 1 |  | 5d | 2024-02-02 A | 2024-02-08 A | 1522 | 100% |  | 2024-02-02 | 2024-02-08 | 5d |  |  |  |  |  | Non-SIT LDSO | Non-SIT LDSO, LDSO , Code Bodies |  | 5.24 | Ben Wickins | Complete | COMPLETE |  |  |  |  |
| 1524 | 1.5.2.2 | **Functional Test Cases & Scenarios Batch 2** |  | 14d | 2024-02-20 A | 2024-03-08 A |  | 100% |  | 2024-02-20 | 2024-03-08 | 14d |  |  |  |  | -0 | N/A | N/A |  | 5.24 | N/A |  |  |  |  |  |  |
| 1525 | 1.5.2.2.1 | Walkthrough Test Cases & Scenarios Batch 2 with Code Bodies |  | 1d | 2024-02-20 A | 2024-02-20 A | 1507SS+75d | 100% |  | 2024-02-20 | 2024-02-20 | 1d |  |  |  |  |  | Non-SIT LDSO | Non-SIT LDSO, Code Bodies |  | 5.24 | Ben Wickins | Complete | COMPLETE |  |  |  |  |
| 1526 | 1.5.2.2.2 | Walkthrough Test Cases & Scenarios Batch 2 with LDSO |  | 1d | 2024-03-01 A | 2024-03-01 A | 1525FS+7d | 100% |  | 2024-03-01 | 2024-03-01 | 1d |  |  |  |  |  | LDSO, Non-SIT LDSO | LDSO, Non-SIT LDSO |  | 5.24 | Ben Wickins | Complete | COMPLETE |  |  |  |  |
| 1527 | 1.5.2.2.3 | Action Feedback on Test Cases & Scenarios Batch 2 |  | 5d | 2024-03-04 A | 2024-03-08 A | 1526 | 100% |  | 2024-03-04 | 2024-03-08 | 5d |  |  |  |  |  | Non-SIT LDSO | Non-SIT LDSO, LDSO , Code Bodies |  | 5.24 | Ben Wickins | Complete | COMPLETE |  |  |  |  |
| 1528 | 1.5.2.3 | **Functional Test Cases & Scenarios Batch 3** |  | 13d | 2024-03-20 A | 2024-04-05 A |  | 100% |  | 2024-03-20 | 2024-04-05 | 13d |  |  |  |  | -0 | N/A | N/A |  | 5.24 | N/A |  |  |  |  |  |  |
| 1529 | 1.5.2.3.1 | Walkthrough Test Cases & Scenarios Batch 3 with Code Bodies |  | 1d | 2024-03-20 A | 2024-03-20 A | 1507SS+96d | 100% |  | 2024-03-20 | 2024-03-20 | 1d |  |  |  |  |  | Non-SIT LDSO | Non-SIT LDSO, Code Bodies |  | 5.24 | Ben Wickins | Complete | COMPLETE |  |  |  |  |
| 1530 | 1.5.2.3.2 | Walkthrough Test Cases & Scenarios Batch 3 with LDSO |  | 1d | 2024-03-28 A | 2024-03-28 A | 1529FS+5d | 100% |  | 2024-03-28 | 2024-03-28 | 1d |  |  |  |  |  | LDSO, Non-SIT LDSO | LDSO, Non-SIT LDSO |  | 5.24 | Ben Wickins | Complete | COMPLETE |  |  |  |  |
| 1531 | 1.5.2.3.3 | Action Feedback on Test Cases & Scenarios Batch 3 |  | 6d | 2024-03-29 A | 2024-04-05 A | 1530 | 100% |  | 2024-03-29 | 2024-04-05 | 6d |  |  |  |  |  | Non-SIT LDSO | Non-SIT LDSO, LDSO , Code Bodies |  | 5.24 | Ben Wickins | Complete | COMPLETE |  |  |  |  |
| 1532 | 1.5.2.4 | Test Cases & Scenarios Batch 1-3 Discussion at QWG |  | 1d | 2024-04-09 A | 2024-04-09 A | 1523, 1527, 1531FS+1d | 100% |  | 2024-04-09 | 2024-04-09 | 1d |  |  |  |  |  | Non-SIT LDSO, PP | Non-SIT LDSO, Code Bodies |  | 5.24 | Ben Wickins | Complete | COMPLETE |  |  |  |  |
| 1533 | 1.5.2.5 | Action QWG Feedback on Test Cases & Scenarios Batch 1-3 |  | 2d | 2024-04-10 A | 2024-04-11 A | 1532 | 100% |  | 2024-04-10 | 2024-04-11 | 2d |  |  |  |  |  | Non-SIT LDSO | Non-SIT LDSO, Code Bodies |  | 5.24 | Ben Wickins | Complete | COMPLETE |  |  |  |  |
| 1534 | 1.5.2.6 | Batch 1-3 Non-SIT LDSO QT Functional Test Scenarios and Test Cases approved | milestone | 0d | 2024-04-18 A | 2024-04-18 A | 1533FS+5d | 100% |  | 2024-04-18 | 2024-04-18 | 0d |  |  |  |  |  | Code Bodies | Non-SIT LDSO, Code Bodies |  | 5.24 | Ben Wickins | Complete | COMPLETE | T3-QU-0069 | QAG (Non-SIT LDSO) |  |  |
| 1535 | 1.5.3 | **Test Execution Schedule** |  | 161d | 2024-04-19 A | 2024-11-29 |  | 99% | 0d | 2024-04-19 | 2024-11-29 | 90d | 2024-01-29 | 2024-04-26 | 799d |  | -0 | N/A | N/A |  | 5.24 | N/A |  |  |  |  | Systems Integration Testing (SIT) |  |
| 1536 | 1.5.3.1 | Draft Test Delivery Schedule for Functional and Operational Testing |  | 20d | 2024-04-19 A | 2024-05-16 A | 1534 | 100% |  | 2024-04-19 | 2024-05-16 | 20d | 2024-01-29 | 2024-03-22 |  |  |  | Non-SIT LDSO | SI Test, PP, Non-SIT LDSO |  | 5.24 | Ben Wickins | Complete | COMPLETE |  |  | Systems Integration Testing (SIT) |  |
| 1537 | 1.5.3.2 | Socialise Test Delivery Schedule with Code Bodies & LDSO for Review & Action Feedback |  | 37d | 2024-05-17 A | 2024-07-08 A | 1536 | 100% |  | 2024-05-17 | 2024-07-08 | 37d |  |  |  |  |  | Non-SIT LDSO | LDSO, Code Bodies, Non-SIT LDSO |  | 5.24 | Ben Wickins | Complete | COMPLETE |  |  |  |  |
| 1538 | 1.5.3.3 | Agree Test Execution Timetable Format at QWG, Including Anonymisation Requirements |  | 1d | 2024-07-09 A | 2024-07-09 A | 1537 | 100% |  | 2024-07-09 | 2024-07-09 | 1d | 2024-03-25 | 2024-04-19 |  |  |  | Non-SIT LDSO, PP | Non-SIT LDSO, Code Bodies |  | 5.24 | Ben Wickins | Complete | COMPLETE |  |  | Systems Integration Testing (SIT) |  |
| 1539 | 1.5.3.4 | Action QWG Feedback |  | 3d | 2024-07-10 A | 2024-07-12 A | 1538 | 100% |  | 2024-07-10 | 2024-07-12 | 3d |  |  |  |  |  | Non-SIT LDSO, PP | Non-SIT LDSO, Code Bodies |  | 5.24 | Ben Wickins | Complete | COMPLETE |  |  |  |  |
| 1540 | 1.5.3.5 | Agree Test Execution Timetable Format at QAG, Including Anonymisation Requirements | milestone | 0d | 2024-07-18 A | 2024-07-18 A | 1539FS+4d | 100% |  | 2024-07-18 | 2024-07-18 | 0d |  |  |  |  |  | Code Bodies | Non-SIT LDSO, Code Bodies |  | 5.29 | Ben Wickins | Complete | COMPLETE | T3-QU-0111 | QAG (Non-SIT LDSO) |  |  |
| 1541 | 1.5.3.6 | Qualification Testing for Non-SIT LDSOs (Functional, Migration, NFT, Operational) Test Execution Schedule Complete | milestone | 0d | 2024-11-29 | 2024-11-29 | 1518 |  |  | 2024-11-29 | 2024-11-29 | 0d | 2024-04-26 | 2024-04-26 | 799d | finish no earlier than 2024-11-29 |  | Non-SIT LDSO | Non-SIT LDSO, Code Bodies, PP | 42.71 | 5.29 | Ben Wickins | Green | RED | T3-QU-0008 | QAG (Non-SIT LDSO) | Systems Integration Testing (SIT) | T3 |
| 1542 | 1.5.4 | **Functional, Non-Functional, Operational & Migration Test Scenarios & Cases** |  | 110d | 2024-03-22 A | 2024-08-22 A |  | 100% |  | 2024-03-22 | 2024-08-22 | 110d |  |  |  |  | -0 | N/A | N/A |  | 5.24 | N/A |  |  |  |  |  |  |
| 1543 | 1.5.4.1 | Test Scenarios & Cases - Functional - Drafted, Reviewed |  | 14d | 2024-04-01 A | 2024-04-18 A | 1512 | 100% |  | 2024-04-01 | 2024-04-18 | 14d |  |  |  |  |  | Non-SIT LDSO | Non-SIT LDSO, LDSO, Code Bodies |  | 5.24 | Ben Wickins | Complete | COMPLETE |  |  |  |  |
| 1544 | 1.5.4.2 | Test Scenarios & Cases- Functional - Approved at QAG | milestone | 0d | 2024-04-18 A | 2024-04-18 A | 1543 | 100% |  | 2024-04-18 | 2024-04-18 | 0d |  |  |  |  |  | Non-SIT LDSO | Non-SIT LDSO, LDSO, Code Bodies |  | 5.24 | Ben Wickins | Complete | COMPLETE | T3-QU-0070 | QAG (Non-SIT LDSO) |  |  |
| 1545 | 1.5.4.3 | Test Scenarios & Cases - Non-Functional - Drafted, Reviewed |  | 110d | 2024-03-22 A | 2024-08-22 A | 1512, 1037FF | 100% |  | 2024-03-22 | 2024-08-22 | 110d |  |  |  |  |  | Non-SIT LDSO | Non-SIT LDSO, LDSO, Code Bodies |  | 5.24 | Ben Wickins | Complete | COMPLETE |  |  |  |  |
| 1546 | 1.5.4.4 | Test Scenarios & Cases - Non-Functional - Approved at QAG | milestone | 0d | 2024-08-22 A | 2024-08-22 A | 1545 | 100% |  | 2024-08-22 | 2024-08-22 | 0d |  |  |  |  |  | Non-SIT LDSO | Non-SIT LDSO, LDSO, Code Bodies |  | 5.29 | Ben Wickins | Complete | COMPLETE | T3-QU-0071 | QAG (Non-SIT LDSO) |  |  |
| 1547 | 1.5.4.5 | Test Scenarios & Cases - Migration - Drafted, Reviewed |  | 45d | 2024-03-22 A | 2024-05-23 A | 1512 | 100% |  | 2024-03-22 | 2024-05-23 | 45d |  |  |  |  |  | Non-SIT LDSO | Non-SIT LDSO, LDSO, Code Bodies |  | 5.24 | Ben Wickins | Complete | COMPLETE |  |  |  |  |
| 1548 | 1.5.4.6 | Test Scenarios & Cases - Migration - Approved at QAG | milestone | 0d | 2024-05-23 A | 2024-05-23 A | 1547 | 100% |  | 2024-05-23 | 2024-05-23 | 0d |  |  |  |  |  | Non-SIT LDSO | Non-SIT LDSO, LDSO, Code Bodies |  | 5.24 | Ben Wickins | Complete | COMPLETE | T3-QU-0072 | QAG (Non-SIT LDSO) |  |  |
| 1549 | 1.5.4.7 | Test Scenarios & Cases - Operational - Drafted, Reviewed |  | 59d | 2024-06-03 A | 2024-08-22 A | 1512FS+51d | 100% |  | 2024-06-03 | 2024-08-22 | 59d |  |  |  |  |  | Non-SIT LDSO | Non-SIT LDSO, LDSO, Code Bodies |  | 5.24 | Ben Wickins | Complete | COMPLETE |  |  |  |  |
| 1550 | 1.5.4.8 | Test Scenarios & Cases - Operational - Approved at QAG | milestone | 0d | 2024-08-22 A | 2024-08-22 A | 1549, 1037FF | 100% |  | 2024-08-22 | 2024-08-22 | 0d |  |  |  |  |  | Non-SIT LDSO | Non-SIT LDSO, LDSO, Code Bodies |  | 5.29 | Ben Wickins | Complete | COMPLETE | T3-QU-0073 | QAG (Non-SIT LDSO) |  |  |

Notes:
- 1534: 13/5: New milestone approved as part of cr47.
- 1541: Date not met because of re-planning activity around SIT Cycle 2 Maintenance window. Maintain dialog with Programme scenario planning from SIT. New forecast date will be defined after programme scenario CR is approved, expected to be 29th November. / Guidance: 18/7/24: Date change from 15/8/24 to 22/8/24 approved at QAG on 18/7/24
- 1544: 13/5: New milestone approved as part of cr47.
- 1546: Date missed because Non-Functional Test Materials are not available for the July QAG. There is no impact the QT window and it will be approved at the August QAG. To go to July QAG for baseline date change / Guidance: 18/7/24: Date change from 18/7/24 to 22/8/24 approved at QAG on 18/7/24
- 1550: Date missed because Operational Test Materials are not available for the July QAG. There is no impact the QT window and it will be approved at the August QAG. To go to July QAG for baseline date change / Guidance: 18/7/24: Date change from 18/7/24 to 22/8/24 approved at QAG on 18/7/24

| ID | WBS | Task | Type | Duration | Start | Finish | Predecessors | Complete | Remaining | Baseline start | Baseline finish | Baseline duration | Total slack | Free slack | Constraint | Deadline | Baseline cost | Responsible | Involved | Task Status | Update Version | MHHS Resource Name | Sched Status | RAG | Milestone ID | Text29 |
| --- | --- | --- | --- | --- | --- | --- | --- | --- | --- | --- | --- | --- | --- | --- | --- | --- | --- | --- | --- | --- | --- | --- | --- | --- | --- | --- |
| 1551 | 1.5.5 | **Test Data** |  | 345d | 2024-01-22 A | 2025-05-16 |  | 44% | 194.37d | 2024-01-22 | 2025-05-16 | 241d | 679d |  |  |  | -0 | N/A | N/A | -385.67 | 5.24 | N/A |  |  |  |  |
| 1552 | 1.5.5.1 | Test Data Plan Drafted & Reviewed |  | 89d | 2024-01-22 A | 2024-05-23 A | 1507 | 100% |  | 2024-01-22 | 2024-05-23 | 89d |  |  |  |  |  | Code Bodies | Non-SIT LDSO, Code Bodies |  | 5.24 | Ben Wickins | Complete | COMPLETE |  |  |
| 1553 | 1.5.5.2 | Non-SIT LDSO QT Test Data Plan Approved by QAG | milestone | 0d | 2024-05-23 A | 2024-05-23 A | 1552 | 100% |  | 2024-05-23 | 2024-05-23 | 0d |  |  |  |  |  | Code Bodies | Non-SIT LDSO, Code Bodies |  | 5.24 | Ben Wickins | Complete | COMPLETE | T3-QU-0074 | QAG (Non-SIT LDSO) |
| 1554 | 1.5.5.3 | Develop Test Data Matrices |  | 10d | 2024-05-24 A | 2024-06-06 A | 1553 | 100% |  | 2024-05-24 | 2024-06-06 | 10d |  |  |  |  |  | Non-SIT LDSO | Non-SIT LDSO |  | 5.24 | Ben Wickins | Complete | COMPLETE |  |  |
| 1555 | 1.5.5.4 | Test Data Cut |  | 17d | 2024-05-24 A | 2024-06-17 A | 1553 | 100% |  | 2024-05-24 | 2024-06-17 | 17d |  |  |  |  |  | PP, Non-SIT LDSO | PP, Non-SIT LDSO |  | 5.24 | Ben Wickins | Complete | COMPLETE |  |  |
| 1556 | 1.5.5.5 | Test Data Cut Complete | milestone | 0d | 2024-06-17 A | 2024-06-17 A | 1555, 1554 | 100% |  | 2024-06-17 | 2024-06-17 | 0d |  |  |  |  |  | PP, Non-SIT LDSO | PP, Non-SIT LDSO |  | 5.27 | Ben Wickins | Complete | COMPLETE | T3-QU-0112 | QAG (Non-SIT LDSO) |
| 1557 | 1.5.5.6 | Test Data Reviewed by the Programme |  | 39d | 2024-06-18 A | 2024-08-09 A | 1556 | 100% |  | 2024-06-18 | 2024-08-09 | 39d |  |  |  |  |  | Non-SIT LDSO | PP, Non-SIT LDSO |  | 5.24 | Ben Wickins | Complete | COMPLETE |  |  |
| 1558 | 1.5.5.7 | Test Data Loaded |  | 85d | 2024-08-12 | 2024-12-06 | 1557 |  |  | 2024-08-12 | 2024-12-06 | 17d | 679d | 0d |  |  |  | Non-SIT LDSO | PP, Non-SIT LDSO | -66.67 | 5.24 | Ben Wickins | Overdue Start | GREEN |  |  |
| 1559 | 1.5.5.8 | Test Data Signed Off | milestone | 0d | 2024-12-06 | 2024-12-06 | 1558 |  |  | 2024-12-06 | 2024-12-06 | 0d | 679d | 0d |  |  |  | Non-SIT LDSO | PP, Non-SIT LDSO | 49.71 | 5.25 | Ben Wickins | Green | AMBER | T3-QU-0113 | QAG (Non-SIT LDSO) |
| 1560 | 1.5.5.9 | Test Execution Data Support |  | 115d | 2024-12-09 | 2025-05-16 | 1559 |  |  | 2024-12-09 | 2025-05-16 | 79d | 679d |  |  |  |  | Non-SIT LDSO | Non-SIT LDSO | 52.33 | 5.24 | Ben Wickins | Green | GREEN |  |  |
| 1561 | 1.5.6 | **Tooling** |  | 148d | 2024-01-31 A | 2024-08-23 A |  | 100% |  | 2024-01-31 | 2024-08-23 | 148d |  |  |  |  | -0 | N/A | N/A | -385.67 | 5.24 | N/A |  |  |  |  |
| 1562 | 1.5.6.1 | Design Approach & Set-Up ADO Tool for Test & Defect Management Tool |  | 53d | 2024-01-31 A | 2024-04-12 A | 1507 | 100% |  | 2024-01-31 | 2024-04-12 | 53d |  |  |  |  |  | Non-SIT LDSO | Non-SIT LDSO, SI Test |  | 5.24 | Ben Wickins | Complete | COMPLETE |  |  |
| 1563 | 1.5.6.2 | Develop Training Requirements & Materials Inc. Day in the Life |  | 87d | 2024-04-15 A | 2024-08-13 A | 1562 | 100% |  | 2024-04-15 | 2024-08-13 | 87d |  |  |  |  |  | Non-SIT LDSO | Non-SIT LDSO, SI Test |  | 5.24 | Ben Wickins | Complete | COMPLETE |  |  |
| 1564 | 1.5.6.3 | ADO Launch complete |  | 1d | 2024-08-23 A | 2024-08-23 A | 1563, 1544, 1548, 1550 | 100% |  | 2024-08-23 | 2024-08-23 | 1d |  |  |  |  |  | Non-SIT LDSO | Non-SIT LDSO |  | 5.24 | Ben Wickins | Complete | COMPLETE |  |  |
| 1565 | 1.5.7 | **Pre-Integration Testing** |  | 218d | 2024-01-31 A | 2024-11-29 |  | 90% | 22.57d | 2024-01-31 | 2024-11-29 | 174d | 799d |  |  |  | -0 | N/A | N/A | -385.67 | 5.24 | N/A |  |  |  |  |
| 1566 | 1.5.7.1 | PIT Guidance & Templates & Approach & Plans Developed |  | 106d | 2024-02-05 A | 2024-07-01 A | 1507FS+3d | 100% |  | 2024-02-05 | 2024-07-01 | 106d |  |  |  |  |  | Non-SIT LDSO | Non-SIT LDSO, LDSO |  | 5.27 | Ben Wickins | Complete | COMPLETE |  |  |
| 1567 | 1.5.7.2 | PIT Test Approach & Plan Deadline for Submission for Non-SIT LDSO​ QT | milestone | 0d | 2024-07-01 A | 2024-07-01 A | 1566 | 100% |  | 2024-07-01 | 2024-07-01 | 0d |  |  |  |  |  | Non-SIT LDSO | Non-SIT LDSO, LDSO |  | 5.28 | Ben Wickins | Complete | COMPLETE | T3-QU-0075 | QAG (Non-SIT LDSO) |
| 1568 | 1.5.7.3 | Develop and agree PIT Test Scenarios |  | 20d | 2024-07-02 A | 2024-07-29 A | 1567 | 100% |  | 2024-07-02 | 2024-07-29 | 31d |  |  |  |  |  | Non-SIT LDSO | Non-SIT LDSO, Code Bodies, LDSO |  | 5.24 | Ben Wickins | Complete | COMPLETE |  |  |
| 1569 | 1.5.7.4 | PIT Execution | manual | 45d | 2024-09-30 A | 2024-11-29 | 1568 | 16% | 38d | 2024-09-30 | 2024-11-29 | 45d |  |  | start no earlier than 2024-09-30 |  |  | Non-SIT LDSO | Non-SIT LDSO, LDSO |  | 5.24 | Ben Wickins | Green | GREEN |  |  |
| 1570 | 1.5.7.5 | Non-SIT LDSO Participants have submitted PIT Test Completion Report & evidence for QT Entry​ | milestone | 0d | 2024-11-29 | 2024-11-29 | 1569 |  |  | 2024-11-29 | 2024-11-29 | 0d | 799d | 15d |  |  |  | Non-SIT LDSO | Non-SIT LDSO, LDSO | 42.71 | 5.24 | Ben Wickins | Green | GREEN | T3-QU-0076 | QAG (Non-SIT LDSO) |
| 1571 | 1.5.7.6 | **Placing Reliance - Code Body & LDSO Functional and Migration** |  | 147d | 2024-01-31 A | 2024-08-22 A |  | 100% |  | 2024-01-31 | 2024-08-22 | 147d |  |  |  |  | -0 | N/A | N/A | -100.67 | 5.24 | N/A |  |  |  |  |
| 1572 | 1.5.7.6.1 | Placing Reliance Submitted & Reviewed |  | 21d | 2024-01-31 A | 2024-02-28 A | 1507 | 100% |  | 2024-01-31 | 2024-02-28 | 21d |  |  |  | 2024-01-05 |  | LDSO, Non-SIT LDSO | LDSO, Non-SIT LDSO |  | 5.24 | Ben Wickins | Complete | COMPLETE |  |  |
| 1573 | 1.5.7.6.2 | Define & Agree QT Testing for Each LDSO |  | 22d | 2024-02-29 A | 2024-03-29 A | 1572 | 100% |  | 2024-02-29 | 2024-03-29 | 22d |  |  |  |  |  | Non-SIT LDSO | LDSO, Non-SIT LDSO |  | 5.24 | Ben Wickins | Complete | COMPLETE |  |  |
| 1574 | 1.5.7.6.3 | Develop Test Scope & Reliance Submissions |  | 20d | 2024-04-01 A | 2024-04-26 A | 1573 | 100% |  | 2024-04-01 | 2024-04-26 | 20d |  |  |  |  |  | Non-SIT LDSO | LDSO, Non-SIT LDSO, Code Bodies |  | 5.24 | Ben Wickins | Complete | COMPLETE |  |  |
| 1575 | 1.5.7.6.4 | Review and Consultation |  | 84d | 2024-04-29 A | 2024-08-22 A | 1574, 1518FF | 100% |  | 2024-04-29 | 2024-08-22 | 84d |  |  |  |  |  | Non-SIT LDSO | LDSO, Non-SIT LDSO |  | 5.27 | Ben Wickins | Complete | COMPLETE |  |  |

Notes:
- 1553: 13/5: New milestone approved as part of cr47. 13/5: Date change to line up with QAG
- 1556: 28/5 LDSO will complete test data cut between 3rd and 17th June
- 1559: Date will be missed due to QT execution replanning. Additionally, the Test Harness will be loaded with dummy suppliers MHHS (outgoing supplier) and MHHX (incoming supplier) for the Change of Supply Test Cases. For messages to flow between DIP, the LDSO systems and the Test Harness the LDSO systems need to be updated with these dummy suppliers. Test data was submitted by LDSOs and team is currently reviewing and filling gaps. Once this is complete, LDSOs can upload to SFTP. Forecast finish date is 06/12/24. / Notes (2): LDSOs will not be able to meet the standards of M10 and achieve Qualification. Through QWG and the LQTSG we have proposed and are discussing solutions with the LDSOs, with a view to achieving full test coverage for all
- 1567: 13/5: New milestone approved as part of cr47. 11/6: Missed date because additional time requested by PPs. 24/6: Approved at QAG on 20/6
- 1570: On track.

| ID | WBS | Task | Type | Duration | Start | Finish | Predecessors | Complete | Remaining | Baseline start | Baseline finish | Baseline duration | Baseline 1 start | Baseline 1 finish | Total slack | Free slack | Constraint | Baseline cost | Responsible | Involved | Task Status | Update Version | MHHS Resource Name | Sched Status | RAG | Milestone ID | Text29 | MHHS Programme Phase | Action | Tier |
| --- | --- | --- | --- | --- | --- | --- | --- | --- | --- | --- | --- | --- | --- | --- | --- | --- | --- | --- | --- | --- | --- | --- | --- | --- | --- | --- | --- | --- | --- | --- |
| 1576 | 1.5.7.7 | **Placing Reliance - Code Body & LDSO Non Functional and Operational** |  | 49d | 2024-06-17 A | 2024-08-22 A |  | 100% |  | 2024-06-17 | 2024-08-22 | 49d |  |  |  |  |  | -0 | N/A | N/A | -100.67 | 5.25 | N/A |  |  |  |  |  |  |  |
| 1577 | 1.5.7.7.1 | Placing Reliance Submitted & Reviewed |  | 32d | 2024-06-17 A | 2024-07-30 A | 1516FF-10d | 100% |  | 2024-06-17 | 2024-07-30 | 32d |  |  |  |  |  |  | LDSO, Non-SIT LDSO | LDSO, Non-SIT LDSO |  | 5.27 | Ben Wickins | Complete | COMPLETE |  |  |  |  |  |
| 1578 | 1.5.7.7.2 | Review and Consultation |  | 17d | 2024-07-31 A | 2024-08-22 A | 1577 | 100% |  | 2024-07-31 | 2024-08-22 | 17d |  |  |  |  |  |  | Non-SIT LDSO | LDSO, Non-SIT LDSO |  | 5.27 | Ben Wickins | Complete | COMPLETE |  |  |  |  |  |
| 1579 | 1.5.7.7.3 | PP Test Scope Presented at QAG | milestone | 0d | 2024-08-22 A | 2024-08-22 A | 1578, 1575 | 100% |  | 2024-08-22 | 2024-08-22 | 0d |  |  |  |  |  |  | Non-SIT LDSO | LDSO, Non-SIT LDSO |  | 5.29 | Ben Wickins | Complete | COMPLETE | T3-QU-0077 | QAG (Non-SIT LDSO) |  |  |  |
| 1580 | 1.5.8 | **LDSO Test Readiness Reporting** |  | 71d | 2024-04-19 A | 2024-07-26 A |  | 100% |  | 2024-04-19 | 2024-07-26 | 118d |  |  |  |  |  | -0 | N/A | N/A |  | 5.24 | N/A |  |  |  |  |  |  |  |
| 1581 | 1.5.8.1 | Interim Test Readiness Report & Plan Developed & Reviewed |  | 71d | 2024-04-19 A | 2024-07-26 A | 1534 | 100% |  | 2024-04-19 | 2024-07-26 | 71d |  |  |  |  |  |  | Non-SIT LDSO, LDSO | Non-SIT LDSO, LDSO |  | 5.24 | Ben Wickins | Complete | COMPLETE |  |  |  |  |  |
| 1582 | 1.5.8.2 | Test Plan Submission to MHHS Programme For Review | milestone | 0d | 2024-07-26 A | 2024-07-26 A | 1581 | 100% |  | 2024-07-26 | 2024-07-26 | 0d |  |  |  |  |  |  | LDSO | Non-SIT LDSO, LDSO |  | 5.30 | Ben Wickins | Complete | COMPLETE | T3-QU-0114 | QAG (Non-SIT LDSO) |  |  |  |
| 1583 | 1.5.9 | **Test Environment** |  | 163d | 2024-04-17 A | 2024-11-29 |  | 37% | 102.02d | 2024-04-17 | 2024-11-29 | 111d | 2024-01-29 | 2024-07-05 | 67d |  |  | -0 | N/A | N/A |  | 5.24 | N/A |  |  |  |  | Systems Integration Testing (SIT) |  |  |
| 1584 | 1.5.9.1 | Define Test Harness Requirements and Sign-Off with SRO |  | 13d | 2024-04-17 A | 2024-05-03 A | 509 | 100% |  | 2024-04-17 | 2024-05-03 | 13d |  |  |  |  |  |  | Non-SIT LDSO | Non-SIT LDSO,SRO,Sims and Ems |  | 5.24 | Ben Wickins | Complete | COMPLETE |  |  |  |  |  |
| 1585 | 1.5.9.2 | Central System (DIP Env & Helix Test Harness) Test Environment DBT |  | 163d | 2024-04-17 A | 2024-11-29 | 509 | 47% | 87d | 2024-04-17 | 2024-11-29 | 92d |  |  | 67d | 0d | finish no earlier than 2024-11-29 |  | LDSO | Non SIT-LDSO, LDSO |  | 5.24 | Ben Wickins | Green | AMBER |  |  |  |  |  |
| 1586 | 1.5.9.3 | Coordinate LDSO Environment Preparation |  | 101d | 2024-07-12 A | 2024-11-29 | 1585FF | 14% | 87d | 2024-07-12 | 2024-11-29 | 30d |  |  | 67d | 0d |  |  | Non-SIT LDSO | Non-SIT LDSO |  | 5.24 | Ben Wickins | Green | GREEN |  |  |  |  |  |
| 1587 | 1.5.9.4 | DIP available for Onboarding |  | 1d | 2024-08-01 A | 2024-08-01 A |  | 100% |  | 2024-08-01 | 2024-08-01 | 1d |  |  |  |  | start no earlier than 2024-08-01 |  | Test Env | Test Env, Non-SIT LDSO |  | 5.24 | Ben Wickins | Complete | COMPLETE |  |  |  | 11/3: Ask Simon B for the link |  |
| 1588 | 1.5.9.5 | Qualification Testing for Non-SIT LDSOs Participants' environments) Ready to start DIP onboarding (incl. certificates and security compliance) | milestone | 0d | 2024-08-05 A | 2024-08-05 A | 1587FS+2d | 100% |  | 2024-08-05 | 2024-08-05 | 0d | 2024-04-26 | 2024-04-26 |  |  |  |  | Non-SIT LDSO | Code Bodies, PP, IPA |  | 5.30 | Ben Wickins | Complete | COMPLETE | T3-QU-0009 | QAG (Non-SIT LDSO) | Systems Integration Testing (SIT) |  | T3 |
| 1589 | 1.5.9.6 | LDSO Test Environments Connection Confirmed to UIT Environment | milestone | 0d | 2024-11-29 | 2024-11-29 | 1588FS+32d, 1586 |  |  | 2024-11-29 | 2024-11-29 | 0d |  |  | 67d | 25d |  |  | Non-SIT LDSO | Code Bodies, PP, IPA | 42.71 | 5.24 | Ben Wickins | Green | AMBER | T3-QU-0078 | QAG (Non-SIT LDSO) |  |  |  |
| 1590 | 1.5.10 | **Test Readiness** |  | 124d | 2024-07-02 A | 2024-12-20 |  | 31% | 85.31d | 2024-07-02 | 2024-12-20 | 76d |  |  | 784d |  |  | -0 | N/A | N/A |  | 5.24 | N/A |  |  |  |  |  |  |  |
| 1591 | 1.5.10.1 | Preparation for Interim Test Readiness Report |  | 19d | 2024-07-02 A | 2024-07-26 A | 1567 | 100% |  | 2024-07-02 | 2024-07-26 | 30d |  |  |  |  |  |  | LDSO | LDSO, Non-SIT LDSO |  | 5.24 | Ben Wickins | Complete | COMPLETE |  |  |  |  |  |
| 1592 | 1.5.10.2 | Interim Test Readiness Report Submission to MHHS Programme for Review | milestone | 0d | 2024-07-26 A | 2024-07-26 A | 1591 | 100% |  | 2024-07-26 | 2024-07-26 | 0d |  |  |  |  |  |  | LDSO | Non-SIT LDSO, LDSO |  | 5.25 | Ben Wickins | Complete | COMPLETE | T3-QU-0116 | QAG (Non-SIT LDSO) |  |  |  |
| 1593 | 1.5.10.3 | LDSO Update Readiness Report & Final Assurance by Programme |  | 99d | 2024-07-29 A | 2024-12-12 | 1592 | 20% | 79d | 2024-07-29 | 2024-12-12 | 25d |  |  | 42d | 0d |  |  | Non-SIT LDSO, LDSO | Non-SIT LDSO, LDSO |  | 5.24 | Ben Wickins | Green | GREEN |  |  |  |  |  |
| 1594 | 1.5.10.4 | Final Test Readiness Report Submitted to MHHS Programme |  | 1d | 2024-12-13 | 2024-12-13 | 1593 |  |  | 2024-12-13 | 2024-12-13 | 1d |  |  | 784d | 0d |  |  | LDSO | Non-SIT LDSO, Code Bodies | 56.33 | 5.24 | Ben Wickins | Green | GREEN |  |  |  |  |  |
| 1595 | 1.5.10.5 | Final Programme Assurance of LDSO Test Readiness |  | 6d | 2024-12-13 | 2024-12-20 | 1593 |  |  | 2024-12-13 | 2024-12-20 | 21d |  |  | 42d | 0d |  |  | Non-SIT LDSO | Non-SIT LDSO, LDSO | 56.33 | 5.24 | Ben Wickins | Green | GREEN |  |  |  |  |  |
| 1596 | 1.5.10.6 | Qualification Testing for Non-SIT LDSOs (Functional, Migration, NFT, Operational) Programme Test Readiness confirmed | milestone | 0d | 2024-12-20 | 2024-12-20 | 1594FS+5d, 1570, 1544, 1546, 1548, 1584 |  |  | 2024-12-20 | 2024-12-20 | 0d | 2024-07-05 | 2024-07-05 | 784d |  |  |  | Non-SIT LDSO | SI Test, PP, Non-SIT LDSO | 63.71 | 5.24 | Ben Wickins | Green | GREEN | T3-QU-0007 | QAG (Non-SIT LDSO) | Systems Integration Testing (SIT) |  | T3 |
| 1597 | 1.5.10.7 | Qualification Testing for Non-SIT LDSOs (Functional, Migration, NFT, Operational) Test Readiness Confirmed (Final Test Readiness Review for LDSO) | milestone | 0d | 2024-12-20 | 2024-12-20 | 1593, 1595 |  |  | 2024-12-20 | 2024-12-20 | 0d | 2024-07-05 | 2024-07-05 | 42d | 0d |  |  | LDSO | SI Test, PP, LDSO | 63.71 | 5.24 | Ben Wickins | Green | GREEN | T2-QU-0550 | QAG (Non-SIT LDSO) | Systems Integration Testing (SIT) |  |  |
| 1598 | 1.5.11 | **Test Window** |  | 94d? | 2025-01-06 | 2025-05-16 |  |  |  | 2025-01-06 | 2025-05-16 | 59d |  |  | 42d |  |  | -0 | N/A | N/A | -527.67 | 5.24 | N/A |  |  |  |  |  |  |  |
| 1599 | 1.5.11.1 | **All Non-SIT LDSOs Qualification Testing** |  | 94d? | 2025-01-06 | 2025-05-16 | 1597, 1589 |  |  | 2025-01-06 | 2025-05-16 | 59d |  |  | 42d | 10d |  |  | LDSO | Non-SIT LDSO,Code Bodies, LDSO | 118.33 | 5.24 | Ben Wickins | Red | RED |  |  |  |  |  |
| 1600 | 1.5.11.1.1 | Non-SIT LDSO QT Test Execution Starts | milestone | 0d | 2025-01-06 | 2025-01-06 | 1597FS+11d |  |  | 2025-01-06 | 2025-01-06 | 0d |  |  | 42d | 0d | start no earlier than 2024-11-01 |  | Non-SIT LDSO | Non-SIT LDSO, LDSO, Code Bodies | 80.71 | 5.25 | Ben Wickins | Green | GREEN | T3-QU-0115 | QAG (Non-SIT LDSO) |  |  |  |
| 1601 | 1.5.11.1.2 | Non-SIT LDSO QT - Migration Testing |  | 20d? | 2025-01-06 | 2025-01-31 | 1600FS-1d |  |  | 2025-01-06 | 2025-01-31 |  |  |  | 42d | 0d |  |  |  |  | 80.33 | 6.0 |  | Green | GREEN | T3-QU-0125 |  |  |  |  |
| 1602 | 1.5.11.1.3 | Non-SIT LDSO QT - Functional Testing |  | 40d? | 2025-02-03 | 2025-03-28 | 1601 |  |  | 2025-02-03 | 2025-03-28 |  |  |  | 42d | 0d |  |  |  |  | 108.33 | 6.0 |  | Green | GREEN | T3-QU-0126 |  |  |  |  |
| 1603 | 1.5.11.1.4 | Non-SIT LDSO QT - Operational Testing |  | 15d? | 2025-03-31 | 2025-04-18 | 1602 |  |  | 2025-03-31 | 2025-04-18 |  |  |  | 52d | 0d |  |  |  |  | 164.33 | 6.0 |  | Green | GREEN | T3-QU-0127 |  |  |  |  |
| 1604 | 1.5.11.1.5 | Non-SIT LDSO QT - Non-Functional Testing |  | 15d? | 2025-04-21 | 2025-05-09 | 1603 |  |  | 2025-04-21 | 2025-05-09 |  |  |  | 52d |  |  |  |  |  | 185.33 | 6.0 |  | Green | GREEN | T3-QU-0128 |  |  |  |  |
| 1605 | 1.5.11.1.6 | Non-SIT LDSO QT - Regression Testing |  | 30d? | 2025-03-31 | 2025-05-09 | 1602 |  |  | 2025-03-31 | 2025-05-09 |  |  |  | 42d | 4d |  |  |  |  | 164.33 | 6.0 |  | Green | GREEN | T3-QU-0129 |  |  |  |  |
| 1606 | 1.5.11.1.7 | Qualification Testing for Non-SIT LDSOs (Functional, Migration, NFT, Operational) 1 End | milestone | 0d | 2025-05-16 | 2025-05-16 | 1605 |  |  | 2025-05-16 | 2025-05-16 | 0d |  |  | 38d | 0d | start no earlier than 2025-05-16 |  |  |  | 210.33 | 5.24 |  | Green | GREEN | T3-QU-0010 |  |  |  |  |

Notes:
- 1579: Date missed because of the update to Supplier and Agent Approach and Plan. Finalised Test Scope will be presented for approval as part of the assurance around the update to Annex 1. To go to July QAG for baseline date change / Guidance: 18/7/24: Date change from 18/7/24 to 22/8/24 approved at QAG on 18/7/24
- 1582: 9 of the expected 12 Interim Test Readiness Reports and are following up with those who are outstanding. These are not a direct requirement of onboarding but a gap analysis ahead of test start
- 1585: 25/09 - End date updated to 29th November.
- 1589: At risk because of DIP env availability for the test harness. (Issue no: I186). Issue will be avoided if start of QT window is delayed
- 1593: 25/09/24 - End date amended to 20/12/24.
- 1596: Date will be missed due to deferral of QT window. Forecast date expected to be 20/12/24 and team on track to deliver against this, but can only be confirmed as baseline once CR55 is formally approved.
- 1597: 13/5: New milestone approved as part of cr47.
- 1599: 17/09/24: New milestones added and date shifted in line with programme recalibration.
- 1600: Forecast finish date expected to be 06/01/25 and team on track to deliver against this, but can only be confirmed as baseline once CR55 is formally approved.
- 1606: 13/5: No change as part of cr47

| ID | WBS | Task | Type | Duration | Start | Finish | Predecessors | Complete | Remaining | Baseline start | Baseline finish | Baseline duration | Baseline 1 start | Baseline 1 finish | Total slack | Free slack | Constraint | Baseline cost | Responsible | Involved | Update Version | MHHS Resource Name | Task Status | Sched Status | RAG | Milestone ID | Text29 | MHHS Programme Phase |
| --- | --- | --- | --- | --- | --- | --- | --- | --- | --- | --- | --- | --- | --- | --- | --- | --- | --- | --- | --- | --- | --- | --- | --- | --- | --- | --- | --- | --- |
| 1607 | 1.5.12 | **Test Result Assurance** |  | 29d | 2025-04-21 | 2025-05-29 |  |  |  | 2025-04-21 | 2025-05-29 | 60d |  |  | 38d |  |  | -0 | N/A | N/A | 5.24 | N/A |  |  |  |  |  |  |
| 1608 | 1.5.12.1 | LDSOs Develop & Submit Test Report (QT Test Completion Report) |  | 19d | 2025-04-21 | 2025-05-16 | 1606FF |  |  | 2025-04-21 | 2025-05-16 | 19d |  |  | 38d | 0d |  |  | LDSO | Non-SIT LDSO, LDSO | 5.24 | Ben Wickins | 185.33 | Green | GREEN |  |  |  |
| 1609 | 1.5.12.2 | Test Reports Reviewed By MHHS & Code Bodies & Finalised |  | 10d | 2025-05-16 | 2025-05-29 | 1608 |  |  | 2025-05-16 | 2025-05-29 | 16d |  |  | 38d | 0d |  |  | Non-SIT LDSO | Non-SIT LDSO, Code Bodies | 5.24 | Ben Wickins | 210.33 | Green | GREEN |  |  |  |
| 1610 | 1.5.12.3 | Non-SIT LDSOs submission deadline for their QT Test Completion Report to MHHS Programme | milestone | 0d | 2025-05-29 | 2025-05-29 | 1609, 1599 |  |  | 2025-05-29 | 2025-05-29 | 0d |  |  | 38d | 0d |  |  | Non-SIT LDSO | Non-SIT LDSO | 5.24 | Ben Wickins | 223.71 | Green | GREEN | T3-QU-0079 | QAG (Non-SIT LDSO) |  |
| 1611 | 1.5.13 | **Non-SIT LDSO Qualification Closure** |  | 61d | 2025-05-30 | 2025-08-22 |  |  |  | 2025-05-30 | 2025-08-22 | 49d |  |  | 22d |  |  | -0 | N/A | N/A | 5.24 | N/A |  |  |  |  |  |  |
| 1612 | 1.5.13.1 | Non-SIT LDSO Qualification Learned Captured |  | 15d | 2025-05-30 | 2025-06-19 | 1610 |  |  | 2025-05-30 | 2025-06-19 | 15d |  |  | 38d | 0d |  |  | Non-SIT LDSO | Non-SIT LDSO | 5.24 | Ben Wickins | 224.33 | Green | GREEN |  |  |  |
| 1613 | 1.5.13.2 | Non-SIT LDSO Qualification Closure Down |  | 5d | 2025-06-20 | 2025-06-26 | 1612 |  |  | 2025-06-20 | 2025-06-26 | 5d |  |  | 38d | 16d |  |  | Non-SIT LDSO | Non-SIT LDSO | 5.24 | Ben Wickins | 245.33 | Green | GREEN |  |  |  |
| 1614 | 1.5.13.3 | BSC PAB & REC Manager approval of Qualification for Non-SIT LDSOs (Start of Migration for Qualification Participants) | milestone | 0d | 2025-08-22 | 2025-08-22 | 1703, 1704, 1613FS+25d |  |  | 2025-08-22 | 2025-08-22 | 0d |  |  | 22d | 0d |  |  | Non-SIT LDSO | Non-SIT LDSO | 5.24 | Ben Wickins | 308.71 | Green | GREEN | T2-QU-0500 | QAG (Non-SIT LDSO) |  |
| 1615 | 1.6 | **S & A QUALIFICATION** |  | 843d | 2023-11-07 A | 2027-01-28 |  | 32% | 570.14d | 2023-11-07 | 2027-01-28 | 603d | 2024-01-29 | 2024-07-05 | 235d |  |  | -0 | N/A | N/A |  | N/A | -461.67 |  |  |  |  | Systems Integration Testing (SIT) |
| 1616 | 1.6.1 | **MHHS Qualification - Qualification Deliverables** |  | 463d | 2023-11-07 A | 2025-08-14 |  | 60% | 185.44d | 2023-11-07 | 2025-08-14 | 349d |  |  | 615d |  |  | -0 | N/A | N/A | 5.24 | N/A | -131.67 |  |  |  |  |  |
| 1617 | 1.6.1.1 | **BSC & REC Assessment Criteria** |  | 463d | 2023-11-07 A | 2025-08-14 |  | 23% | 356.15d | 2023-11-07 | 2025-08-14 | 212d |  |  | 615d |  |  | -0 | N/A | N/A | 5.24 | N/A | -131.67 |  |  |  |  |  |
| 1618 | 1.6.1.1.1 | Draft BSC Assessment Criteria (Functional) |  | 21d | 2023-11-07 A | 2023-12-05 A |  | 100% |  | 2023-11-07 | 2023-12-05 | 21d |  |  |  |  | finish no earlier than 2023-12-05 |  | Code Bodies | Code Bodies | 5.24 | Laura Kennedy |  | Complete | COMPLETE |  |  |  |
| 1619 | 1.6.1.1.2 | BSC PAB Review |  | 1d | 2023-12-14 A | 2023-12-14 A |  | 100% |  | 2023-12-14 | 2023-12-14 | 1d |  |  |  |  | start no earlier than 2023-12-14 |  | Code Bodies | Code Bodies | 5.24 | Laura Kennedy |  | Complete | COMPLETE |  |  |  |
| 1620 | 1.6.1.1.3 | Update BSC Assessment Criteria (Functional, Non-Functional, Migration) |  | 30d | 2024-02-07 A | 2024-03-19 A |  | 100% |  | 2024-02-07 | 2024-03-19 | 30d |  |  |  |  | finish no earlier than 2024-03-19 |  | Code Bodies | Code Bodies | 5.24 | Laura Kennedy |  | Complete | COMPLETE |  |  |  |
| 1621 | 1.6.1.1.4 | REC & BSC PAB Approval |  | 3d | 2024-03-26 A | 2024-03-28 A |  | 100% |  | 2024-03-26 | 2024-03-28 | 3d |  |  |  |  | start no earlier than 2024-03-28 |  | Code Bodies | Code Bodies | 5.24 | Laura Kennedy |  | Complete | COMPLETE |  |  |  |
| 1622 | 1.6.1.1.5 | Update BSC Assessment Criteria (Functional, Non-Functional, Migration, Operational) |  | 20d | 2024-07-24 A | 2024-08-20 A |  | 100% |  | 2024-07-24 | 2024-08-20 | 20d |  |  |  |  |  |  | Code Bodies | Code Bodies | 5.24 | Laura Kennedy |  | Complete | COMPLETE |  |  |  |
| 1623 | 1.6.1.1.6 | Assessment Criteria (Functional, Non-Functional, Migration, Operational) Approved by REC PAB and BSC PAB |  | 250d | 2024-08-29 | 2025-08-14 | 1622FS+7d |  |  | 2024-08-29 | 2025-08-14 | 0d |  |  | 615d |  | start no earlier than 2023-09-15 |  | Code Bodies | Code Bodies | 5.25 | Laura Kennedy | -49.29 | Green | GREEN | T3-QU-0080 | QAG |  |
| 1624 | 1.6.1.2 | **Qualification Approach and Plan** |  | 194d | 2023-12-04 A | 2024-08-29 A |  | 100% |  | 2023-12-04 | 2024-08-29 | 194d |  |  |  |  |  | -0 | N/A | N/A | 5.24 | N/A | -131.67 |  |  |  |  |  |
| 1625 | 1.6.1.2.1 | **Qualification Approach and Plan v2** |  | 84d | 2023-12-04 A | 2024-03-28 A |  | 100% |  | 2023-12-04 | 2024-03-28 | 84d |  |  |  |  |  | -0 | N/A | N/A | 5.24 | N/A | -131.67 |  |  |  |  |  |
| 1626 | 1.6.1.2.1.1 | Draft Qualification Approach and Plan v2 |  | 30d | 2023-12-04 A | 2024-01-12 A |  | 100% |  | 2023-12-04 | 2024-01-12 | 30d |  |  |  |  | finish no earlier than 2024-01-12 |  | Code Bodies | Code Bodies | 5.24 | Laura Kennedy |  | Complete | COMPLETE |  |  |  |
| 1627 | 1.6.1.2.1.2 | Internal Review (Code Bodies and MHHSP) for Qualification Approach and Plan V2 |  | 10d | 2024-01-15 A | 2024-01-26 A | 1626 | 100% |  | 2024-01-15 | 2024-01-26 | 10d |  |  |  |  | finish no earlier than 2024-01-26 |  | Code Bodies, SI Team, SRO | Code Bodies, SI Team, SRO | 5.24 | Laura Kennedy |  | Complete | COMPLETE |  |  |  |
| 1628 | 1.6.1.2.1.3 | Industry consultation for Qualification Approach and Plan v2 |  | 11d | 2024-01-31 A | 2024-02-14 A | 1627 | 100% |  | 2024-01-31 | 2024-02-14 | 11d |  |  |  |  | start no earlier than 2024-01-31 |  | Participants | Participants | 5.24 | Laura Kennedy |  | Complete | COMPLETE |  |  |  |
| 1629 | 1.6.1.2.1.4 | Update Qualification Approach and Plan v2 post industry consultation |  | 10d | 2024-02-15 A | 2024-02-28 A | 1628 | 100% |  | 2024-02-15 | 2024-02-28 | 10d |  |  |  |  |  |  | Code Bodies | Code Bodies | 5.24 | Laura Kennedy |  | Complete | COMPLETE |  |  |  |
| 1630 | 1.6.1.2.1.5 | QWG Endorsement of Qualification Approach and Plan v2 |  | 1d | 2024-03-12 A | 2024-03-12 A |  | 100% |  | 2024-03-12 | 2024-03-12 | 1d |  |  |  |  | start no earlier than 2024-03-12 |  | Code Bodies | Code Bodies | 5.24 | Laura Kennedy |  | Complete | COMPLETE |  |  |  |
| 1631 | 1.6.1.2.1.6 | QAG Approval of Qualification Approach and Plan v2 |  | 1d | 2024-03-21 A | 2024-03-21 A |  | 100% |  | 2024-03-21 | 2024-03-21 | 1d |  |  |  |  | start no earlier than 2024-03-21 |  | Code Bodies | Code Bodies | 5.24 | Laura Kennedy |  | Complete | COMPLETE |  |  |  |
| 1632 | 1.6.1.2.1.7 | BSC and REC PAB Approval of Qualification Approach and Plan v2 |  | 3d | 2024-03-26 A | 2024-03-28 A |  | 100% |  | 2024-03-26 | 2024-03-28 | 3d |  |  |  |  | finish no earlier than 2024-03-28 |  | Code Bodies | Code Bodies | 5.24 | Laura Kennedy |  | Complete | COMPLETE |  |  |  |
| 1633 | 1.6.1.2.1.8 | Functional Testing elements of Qualification Approach & Plan v2 approvement by REC PAB and BSC PAB | milestone | 0d | 2024-03-28 A | 2024-03-28 A | 1632 | 100% |  | 2024-03-28 | 2024-03-28 | 0d |  |  |  |  |  |  | Code Bodies | Code Bodies | 5.24 | Laura Kennedy |  | Complete | COMPLETE | T3-QU-0063 | QAG |  |
| 1634 | 1.6.1.2.1.9 | Migration Testing elements of Qualification Approach & Plan v2 appoved by REC PAB and BSC PAB | milestone | 0d | 2024-03-28 A | 2024-03-28 A | 1632 | 100% |  | 2024-03-28 | 2024-03-28 | 0d |  |  |  |  |  |  | Code Bodies | Code Bodies | 5.24 | Laura Kennedy |  | Complete | COMPLETE | T3-QU-0064 | QAG |  |

Notes:
- 1610: 25/09/24 - Baseline finish to be updated once CR55 formally approved, this will be 29/05/25. In the meantime, team is still assessing the impact this new forecast date will have on NF PIT timelines.
- 1614: 13/5: name changed as part of cr47.
- 1623: Assessment criteria is going to PAB for approval on 26/09/24, expecetd to be complete.

| ID | WBS | Task | Type | Duration | Start | Finish | Predecessors | Complete | Remaining | Baseline start | Baseline finish | Baseline duration | Total slack | Constraint | Baseline cost | Responsible | Involved | Task Status | Update Version | MHHS Resource Name | Sched Status | RAG | Milestone ID | Text29 |
| --- | --- | --- | --- | --- | --- | --- | --- | --- | --- | --- | --- | --- | --- | --- | --- | --- | --- | --- | --- | --- | --- | --- | --- | --- |
| 1635 | 1.6.1.2.2 | **Qualification Approach and Plan v3** |  | 84d | 2024-05-06 A | 2024-08-29 A |  | 100% |  | 2024-05-06 | 2024-08-29 | 84d |  |  | -0 | N/A | N/A | -133.67 | 5.24 | N/A |  |  |  |  |
| 1636 | 1.6.1.2.2.1 | Draft Qualification Approach and Plan v3 |  | 35d | 2024-05-06 A | 2024-06-21 A | 1020 | 100% |  | 2024-05-06 | 2024-06-21 | 35d |  | finish no earlier than 2024-05-17 |  | Code Bodies | Code Bodies |  | 5.27 | Laura Kennedy | Complete | COMPLETE |  |  |
| 1637 | 1.6.1.2.2.2 | Internal Review (Code Bodies and MHHSP) of Qualification Approach and Plan v3 |  | 10d | 2024-06-24 A | 2024-07-05 A | 1636 | 100% |  | 2024-06-24 | 2024-07-05 | 10d |  |  |  | Code Bodies, SI Team, SRO | Code Bodies, SI Team, SRO |  | 5.27 | Laura Kennedy | Complete | COMPLETE |  |  |
| 1638 | 1.6.1.2.2.3 | Industry consultation for Qualification Approach and Plan v3 |  | 10d | 2024-07-08 A | 2024-07-19 A | 1637 | 100% |  | 2024-07-08 | 2024-07-19 | 10d |  |  |  | Participants | Participants |  | 5.27 | Laura Kennedy | Complete | COMPLETE |  |  |
| 1639 | 1.6.1.2.2.4 | Update Qualification Approach and Plan v3 Post-Consultation |  | 10d | 2024-07-22 A | 2024-08-02 A | 1638 | 100% |  | 2024-07-22 | 2024-08-02 | 10d |  |  |  | Code Bodies | Code Bodies |  | 5.27 | Laura Kennedy | Complete | COMPLETE |  |  |
| 1640 | 1.6.1.2.2.5 | QWG Endorsement of Qualification Approach and Plan v3 |  | 1d | 2024-08-13 A | 2024-08-13 A | 1639FS+6d | 100% |  | 2024-08-13 | 2024-08-13 | 1d |  |  |  | Code Bodies | Code Bodies |  | 5.27 | Laura Kennedy | Complete | COMPLETE |  |  |
| 1641 | 1.6.1.2.2.6 | QAG Approval of Qualification Approach and Plan v3 | milestone | 0d | 2024-08-22 A | 2024-08-22 A | 1640FS+7d | 100% |  | 2024-08-22 | 2024-08-22 | 0d |  |  |  | Code Bodies | Code Bodies |  | 5.27 | Laura Kennedy | Complete | COMPLETE | T3-QU-0081 | QAG |
| 1642 | 1.6.1.2.2.7 | BSC and REC PAB Approval of Qualification Approach and Plan v3 |  | 3d | 2024-08-27 A | 2024-08-29 A | 1641FS+2d | 100% |  | 2024-08-27 | 2024-08-29 | 3d |  |  |  | Code Bodies | Code Bodies |  | 5.27 | Laura Kennedy | Complete | COMPLETE |  |  |
| 1643 | 1.6.1.2.2.8 | Non-Functional Testing elements of Qualification Approach and Plan v3 approved by REC PAB and BSC PAB | milestone | 0d | 2024-08-29 A | 2024-08-29 A | 1642 | 100% |  | 2024-08-29 | 2024-08-29 | 0d |  |  |  | Code Bodies | Code Bodies |  | 5.27 | Laura Kennedy | Complete | COMPLETE | T3-QU-0065 | QAG |
| 1644 | 1.6.1.3 | **Qualification Assessment Document** |  | 316d | 2023-12-22 A | 2025-03-07 |  | 81% | 60.38d | 2023-12-22 | 2025-03-07 | 316d | 633d |  | -0 | N/A | N/A | -131.67 | 5.24 | N/A |  |  |  |  |
| 1645 | 1.6.1.3.1 | **Qualification Assessment Document v1** |  | 70d | 2023-12-22 A | 2024-03-28 A |  | 100% |  | 2023-12-22 | 2024-03-28 | 70d |  |  | -0 | N/A | N/A | -131.67 | 5.24 | N/A |  |  |  |  |
| 1646 | 1.6.1.3.1.1 | Draft Qualification Assessment Document v1 |  | 30d | 2023-12-22 A | 2024-02-01 A |  | 100% |  | 2023-12-22 | 2024-02-01 | 30d |  | finish no earlier than 2024-02-01 |  | Code Bodies | Code Bodies |  | 5.24 | Laura Kennedy | Complete | COMPLETE |  |  |
| 1647 | 1.6.1.3.1.2 | Internal Review (Code Bodies and MHHSP) of Qualification Assessment Document v1 |  | 10d | 2024-02-01 A | 2024-02-14 A |  | 100% |  | 2024-02-01 | 2024-02-14 | 10d |  | finish no earlier than 2024-02-14 |  | Code Bodies, SI Team, SRO | Code Bodies, SI Team, SRO |  | 5.24 | Laura Kennedy | Complete | COMPLETE |  |  |
| 1648 | 1.6.1.3.1.3 | Industry consultation for Qualification Assessment Document v1 |  | 11d | 2024-02-16 A | 2024-03-01 A |  | 100% |  | 2024-02-16 | 2024-03-01 | 11d |  | start no earlier than 2024-02-16 |  | Participants | Participants |  | 5.24 | Laura Kennedy | Complete | COMPLETE |  |  |
| 1649 | 1.6.1.3.1.4 | Update Post-Consultation for Qualification Assessment Document v1 |  | 10d | 2024-03-04 A | 2024-03-15 A | 1648 | 100% |  | 2024-03-04 | 2024-03-15 | 10d |  |  |  | Code Bodies | Code Bodies |  | 5.24 | Laura Kennedy | Complete | COMPLETE |  |  |
| 1650 | 1.6.1.3.1.5 | BSC and REC PAB Approval of Qualification Assessment Document v1 |  | 3d | 2024-03-26 A | 2024-03-28 A |  | 100% |  | 2024-03-26 | 2024-03-28 | 3d |  | start no earlier than 2024-03-26 |  | Code Bodies | Code Bodies |  | 5.24 | Laura Kennedy | Complete | COMPLETE |  |  |
| 1651 | 1.6.1.3.1.6 | Qualification Assessment Document v1 approved by REC PAB and BSC PAB | milestone | 0d | 2024-03-28 A | 2024-03-28 A | 1650 | 100% |  | 2024-03-28 | 2024-03-28 | 0d |  |  |  | Code Bodies | Code Bodies |  | 5.24 | Laura Kennedy | Complete | COMPLETE | T3-QU-0066 | QAG |
| 1652 | 1.6.1.3.2 | **Qualification Assessment Document v3** |  | 110d | 2024-03-29 A | 2024-08-29 A |  | 100% |  | 2024-03-29 | 2024-08-29 | 110d |  |  | -0 | N/A | N/A | -131.67 | 5.24 | N/A |  |  |  |  |
| 1653 | 1.6.1.3.2.1 | Draft Qualification Assessment Document V1.1 |  | 26d | 2024-03-29 A | 2024-05-03 A | 1651 | 100% |  | 2024-03-29 | 2024-05-03 | 26d |  |  |  |  |  |  | 5.24 | Laura Kennedy | Complete | COMPLETE |  |  |
| 1654 | 1.6.1.3.2.2 | Industry Consultation for Qualification Assessment Document V1.1 |  | 12d | 2024-05-06 A | 2024-05-21 A | 1653 | 100% |  | 2024-05-06 | 2024-05-21 | 12d |  |  |  |  |  |  | 5.24 | Laura Kennedy | Complete | COMPLETE |  |  |
| 1655 | 1.6.1.3.2.3 | Draft Qualification Assessment Document v3 |  | 6d | 2024-06-14 A | 2024-06-21 A | 1103, 1654 | 100% |  | 2024-06-14 | 2024-06-21 | 6d |  |  |  | Code Bodies | Code Bodies |  | 5.24 | Laura Kennedy | Complete | COMPLETE |  |  |
| 1656 | 1.6.1.3.2.4 | Internal Review (Code Bodies and MHHSP) of Qualification Assessment Document v3 |  | 10d | 2024-06-24 A | 2024-07-05 A | 1655 | 100% |  | 2024-06-24 | 2024-07-05 | 10d |  |  |  | Code Bodies, SI Team, SRO | Code Bodies, SI Team, SRO |  | 5.24 | Laura Kennedy | Complete | COMPLETE |  |  |
| 1657 | 1.6.1.3.2.5 | Industry consultation for Qualification Assessment Document v3 |  | 10d | 2024-07-08 A | 2024-07-19 A | 1656 | 100% |  | 2024-07-08 | 2024-07-19 | 10d |  |  |  | Participants | Participants |  | 5.24 | Laura Kennedy | Complete | COMPLETE |  |  |
| 1658 | 1.6.1.3.2.6 | Update Post-Consultation for Qualification Assessment Document v3 |  | 10d | 2024-07-22 A | 2024-08-02 A | 1657 | 100% |  | 2024-07-22 | 2024-08-02 | 10d |  |  |  | Code Bodies | Code Bodies |  | 5.24 | Laura Kennedy | Complete | COMPLETE |  |  |
| 1659 | 1.6.1.3.2.7 | QWG Endorsement of Qualification Assessment Document v3 |  | 1d | 2024-08-13 A | 2024-08-13 A | 1658FS+6d | 100% |  | 2024-08-13 | 2024-08-13 | 1d |  |  |  | Code Bodies | Code Bodies |  | 5.24 | Laura Kennedy | Complete | COMPLETE |  |  |
| 1660 | 1.6.1.3.2.8 | QAG Endorsement of Qualification Assessment Document v3 |  | 1d | 2024-08-22 A | 2024-08-22 A | 1659FS+6d | 100% |  | 2024-08-22 | 2024-08-22 | 1d |  |  |  | Code Bodies | Code Bodies |  | 5.25 | Laura Kennedy | Complete | COMPLETE | T3-QU-0083 | QAG |
| 1661 | 1.6.1.3.2.9 | BSC and REC PAB Approval of Qualification Assessment Document v3 |  | 3d | 2024-08-27 A | 2024-08-29 A | 1660FS+2d | 100% |  | 2024-08-27 | 2024-08-29 | 3d |  |  |  | Code Bodies | Code Bodies |  | 5.24 | Laura Kennedy | Complete | COMPLETE |  |  |
| 1662 | 1.6.1.3.2.10 | Qualification Assessment Document v3 approved by REC PAB and BSC PAB | milestone | 0d | 2024-08-29 A | 2024-08-29 A | 1661 | 100% |  | 2024-08-29 | 2024-08-29 | 0d |  |  |  | Code Bodies | Code Bodies |  | 5.24 | Laura Kennedy | Complete | COMPLETE | T3-QU-0067 | QAG |

Notes:
- 1641: Approved at QAG on 22/08/24.
- 1660: Approved at QAG on 22/08/24.

| ID | WBS | Task | Type | Duration | Start | Finish | Predecessors | Complete | Remaining | Baseline start | Baseline finish | Baseline duration | Baseline 1 start | Baseline 1 finish | Total slack | Free slack | Constraint | Baseline cost | Responsible | Involved | Task Status | Update Version | MHHS Resource Name | Sched Status | RAG | Milestone ID | Text29 | MHHS Programme Phase |
| --- | --- | --- | --- | --- | --- | --- | --- | --- | --- | --- | --- | --- | --- | --- | --- | --- | --- | --- | --- | --- | --- | --- | --- | --- | --- | --- | --- | --- |
| 1663 | 1.6.1.3.3 | **Qualification Assessment Document Portal** |  | 285d | 2024-02-05 A | 2025-03-07 |  | 65% | 100d | 2024-02-05 | 2025-03-07 | 285d |  |  | 633d |  |  | -0 | N/A | N/A | -131.67 | 5.24 | N/A |  |  |  |  |  |
| 1664 | 1.6.1.3.3.1 | Design Completion |  | 30d | 2024-02-05 A | 2024-03-15 A |  | 100% |  | 2024-02-05 | 2024-03-15 | 30d |  |  |  |  | finish no earlier than 2024-03-15 |  | QAD Portal Dev Team | QAD Portal Dev Team |  | 5.24 | Laura Kennedy | Complete | COMPLETE |  |  |  |
| 1665 | 1.6.1.3.3.2 | Qualification Assessment Document Portal Build |  | 30d | 2024-03-18 A | 2024-04-26 A | 1664 | 100% |  | 2024-03-18 | 2024-04-26 | 30d |  |  |  |  |  |  | QAD Portal Dev Team | QAD Portal Dev Team |  | 5.24 | Laura Kennedy | Complete | COMPLETE |  |  |  |
| 1666 | 1.6.1.3.3.3 | Qualification Assessment Document Internal Testing |  | 20d | 2024-04-29 A | 2024-05-24 A | 1665 | 100% |  | 2024-04-29 | 2024-05-24 | 20d |  |  |  |  |  |  | QAD Portal Dev Team. Code Bodies | QAD Portal Dev Team. Code Bodies |  | 5.24 | Laura Kennedy | Complete | COMPLETE |  |  |  |
| 1667 | 1.6.1.3.3.4 | Qualification Assessment Document Portal Training and Onboarding Material Creation |  | 20d | 2024-05-27 A | 2024-06-21 A | 1666 | 100% |  | 2024-05-27 | 2024-06-21 | 20d |  |  |  |  |  |  | QAD Portal Dev Team | QAD Portal Dev Team |  | 5.24 | Laura Kennedy | Complete | COMPLETE |  |  |  |
| 1668 | 1.6.1.3.3.5 | Qualification Assessment Document Portal Webinar (Date TBC) |  | 1d | 2024-06-18 A | 2024-06-18 A |  | 100% |  | 2024-06-18 | 2024-06-18 | 1d |  |  |  |  | start no earlier than 2024-06-18 |  | QAD Portal Dev Team | QAD Portal Dev Team |  | 5.24 | Laura Kennedy | Complete | COMPLETE |  |  |  |
| 1669 | 1.6.1.3.3.6 | SIT Participant QAD Application Creation in Portal |  | 10d | 2024-08-12 | 2024-08-23 | 1667FS+35d |  |  | 2024-08-12 | 2024-08-23 | 10d |  |  | 773d | 0d |  |  | Code Bodies | Code Bodies | -66.67 | 5.24 | Laura Kennedy | Overdue Start | RED |  |  |  |
| 1670 | 1.6.1.3.3.7 | Non-SIT LDSO Participant QAD Application Creation in Portal |  | 10d | 2024-08-12 | 2024-08-23 | 1667FS+35d |  |  | 2024-08-12 | 2024-08-23 | 10d |  |  | 773d | 0d |  |  | Code Bodies | Code Bodies | -66.67 | 5.24 | Laura Kennedy | Overdue Start | RED |  |  |  |
| 1671 | 1.6.1.3.3.8 | QT Wave 1 Participant QAD Application Creation in Portal |  | 10d | 2024-09-23 | 2024-10-04 | 1667FS+65d |  |  | 2024-09-23 | 2024-10-04 | 10d |  |  | 36d | 0d |  |  | Code Bodies | Code Bodies | -24.67 | 5.24 | Laura Kennedy | Green | GREEN |  |  |  |
| 1672 | 1.6.1.3.3.9 | QT Wave 2 Participant QAD Application Creation in Portal |  | 10d | 2024-10-28 | 2024-11-08 | 1667FS+90d |  |  | 2024-10-28 | 2024-11-08 | 10d |  |  | 6d | 0d |  |  | Code Bodies | Code Bodies | 10.33 | 5.27 | Laura Kennedy | Green | GREEN |  |  |  |
| 1673 | 1.6.1.3.3.10 | QT Wave 3 Participant QAD Application Creation in Portal |  | 10d | 2024-12-30 | 2025-01-10 | 1667FS+135d |  |  | 2024-12-30 | 2025-01-10 | 10d |  |  | 0d |  |  |  | Code Bodies | Code Bodies | 73.33 | 5.27 | Laura Kennedy | Green | GREEN |  |  |  |
| 1674 | 1.6.1.3.3.11 | QT Wave 4 Participant QAD Application Creation in Portal |  | 10d | 2025-02-24 | 2025-03-07 | 1667FS+175d |  |  | 2025-02-24 | 2025-03-07 | 10d |  |  | 4d | 0d |  |  | Code Bodies | Code Bodies | 129.33 | 5.27 | Laura Kennedy | Green | GREEN |  |  |  |
| 1675 | 1.6.1.3.3.12 | Update to Qualification Assessment Document Portal post QAD V3 |  | 10d | 2024-08-30 A | 2024-09-12 A | 1662 | 100% |  | 2024-08-30 | 2024-09-12 | 10d |  |  |  |  |  |  | QAD Portal Dev Team | QAD Portal Dev Team |  | 5.24 | Laura Kennedy | Complete | COMPLETE |  |  |  |
| 1676 | 1.6.1.3.3.13 | Update to Qualification Assessment Document Portal post QAD V3 Complete | milestone | 0d | 2024-09-12 A | 2024-09-12 A | 1675 | 100% |  | 2024-09-12 | 2024-09-12 | 0d |  |  |  |  |  |  | QAD Portal Dev Team | QAD Portal Dev Team |  | 5.25 | Laura Kennedy | Complete | COMPLETE | T3-QU-0084 | QAG |  |
| 1677 | 1.6.2 | **MHHS Qualification - SIT Participants** |  | 251d | 2025-01-06 | 2025-12-22 |  |  |  | 2025-01-06 | 2025-12-22 | 194d | 2024-01-29 | 2024-07-05 | 60d |  |  | -0 | N/A | N/A | -133.67 | 5.24 | N/A |  |  |  |  | Systems Integration Testing (SIT) |
| 1678 | 1.6.2.1 | Initial QAD Submission Window opens | milestone | 0d | 2025-01-06 | 2025-01-06 | 1669FS+96d |  |  | 2025-01-06 | 2025-01-06 | 0d |  |  | 773d |  | start no earlier than 2025-01-06 |  | Participants | Participants | 80.71 | 5.24 | Laura Kennedy | Green | GREEN |  |  |  |
| 1679 | 1.6.2.2 | SIT Participants submit Initial QAD |  | 30d | 2025-01-06 | 2025-02-14 |  |  |  | 2025-01-06 | 2025-02-14 | 29d |  |  | 60d | 0d | start no earlier than 2025-01-06 |  | Participants | Participants | 80.33 | 5.24 | Laura Kennedy | Green | GREEN |  |  |  |
| 1680 | 1.6.2.3 | Code Bodies review Initial QAD |  | 36d | 2025-02-14 | 2025-04-04 | 1679FS-1d |  |  | 2025-02-14 | 2025-04-04 | 36d |  |  | 60d | 0d |  |  | Code Bodies | Code Bodies | 119.33 | 5.24 | Laura Kennedy | Green | GREEN |  |  |  |
| 1681 | 1.6.2.4 | Completion of Code Bodies review of Initial QAD | milestone | 0d | 2025-04-04 | 2025-04-04 | 1680 |  |  | 2025-04-04 | 2025-04-04 | 0d |  |  | 60d | 0d |  |  | Code Bodies | Code Bodies | 168.71 | 5.24 | Laura Kennedy | Green | GREEN |  |  |  |
| 1682 | 1.6.2.5 | **MHHS Qualification - SIT MVC Participants** |  | 114d | 2025-04-07 | 2025-09-11 |  |  |  | 2025-04-07 | 2025-09-11 | 64d |  |  | 5d |  |  |  | N/A | N/A | -154.67 | 5.24 | N/A |  |  |  |  |  |
| 1683 | 1.6.2.5.1 | Final QAD Submission Window (MVC) opens | milestone | 0d | 2025-04-07 | 2025-04-07 | 1680, 1676, 1681FS+1d |  |  | 2025-04-07 | 2025-04-07 | 0d |  |  | 60d | 0d |  |  | Participants | Participants | 171.71 | 5.24 | Laura Kennedy | Green | GREEN |  |  |  |
| 1684 | 1.6.2.5.2 | SIT MVC Participants submit Final QAD |  | 25d | 2025-04-07 | 2025-05-09 | 1683FS-1d |  |  | 2025-04-07 | 2025-05-09 | 26d |  |  | 60d | 0d |  |  | Participants | Participants | 171.33 | 5.24 | Laura Kennedy | Green | GREEN |  |  |  |
| 1685 | 1.6.2.5.3 | Completion of Code Bodies review of Final QAD (MVC) |  | 20d | 2025-05-12 | 2025-06-06 | 1684, 1347FF |  |  | 2025-05-12 | 2025-06-06 | 19d |  |  | 60d | 55d |  |  | Code Bodies | Code Bodies | 206.33 | 5.24 | Laura Kennedy | Green | GREEN |  |  |  |
| 1686 | 1.6.2.5.4 | QAD Sign Off Deadline (MVC) | milestone | 0d | 2025-08-22 | 2025-08-22 | 1356, 1685 |  |  | 2025-08-22 | 2025-08-22 | 1d |  |  | 5d | 0d | start no earlier than 2025-07-11 |  | Participants | Participants | 308.71 | 5.24 | Laura Kennedy | Green | GREEN |  |  |  |
| 1687 | 1.6.2.5.5 | REC Code Manager / BSC PAB Approval of Qualification (MVC) | milestone | 0d | 2025-09-11 | 2025-09-11 | 1686FS+14d |  |  | 2025-09-11 | 2025-09-11 | 0d |  |  | 5d | 0d |  |  | Code Bodies | Code Bodies | 328.71 | 5.25 | Laura Kennedy | Green | AMBER | T3-QU-0085 | QAG |  |

Notes:
- 1669: 25/09/24 - These should move to start a week before the QAD window.
- 1670: 25/09/24 - These should move to start a week before the QAD window.
- 1671: 25/09/24 - These should move to start a week before the QAD window.
- 1672: 25/09/24 - Proposed that this is removed and replaced with a milestone for Batch 3 of Functional Tests, but this has not yet been confirmed.
- 1678: 25/09/24 - Forecast has moved to 06/01/25, this will be baseliend once CR55 is approved.
- 1679: 25/09/24 - Forecast has moved to 13/02/25, this will be baseliend once CR55 is approved.
- 1680: 25/09/24 - Forecast has moved to 04/04/25, this will be baseliend once CR55 is approved.
- 1681: 25/09/24 - Forecast has moved to 04/04/25, this will be baseliend once CR55 is approved.
- 1683: 25/09/24 - Forecast has moved to 04/04/25, this will be baseliend once CR55 is approved.
- 1687: 6/8/24: Date at risk from scenario planning activity

| ID | WBS | Task | Type | Duration | Start | Finish | Predecessors | Complete | Remaining | Baseline start | Baseline finish | Baseline duration | Total slack | Free slack | Constraint | Baseline cost | Responsible | Involved | Task Status | Update Version | MHHS Resource Name | Sched Status | RAG | Milestone ID | Text29 |
| --- | --- | --- | --- | --- | --- | --- | --- | --- | --- | --- | --- | --- | --- | --- | --- | --- | --- | --- | --- | --- | --- | --- | --- | --- | --- |
| 1688 | 1.6.2.6 | **MHHS Qualification - SIT Non-MVC Participants** |  | 156d | 2025-05-19 | 2025-12-22 |  |  |  | 2025-05-19 | 2025-12-22 | 129d | 25d |  |  |  | N/A | N/A | -154.67 | 5.24 | N/A |  |  |  |  |
| 1689 | 1.6.2.6.1 | Final QAD Submission Window (Non-MVC) opens | milestone | 0d | 2025-05-19 | 2025-05-19 | 1681FS+31d |  |  | 2025-05-19 | 2025-05-19 | 0d | 134d | 0d |  |  | Participants | Participants | 213.71 | 5.24 | Laura Kennedy | Green | GREEN |  |  |
| 1690 | 1.6.2.6.2 | SIT Non-MVC Participants submit Final QAD |  | 90d | 2025-05-19 | 2025-09-19 | 1689SS-1d |  |  | 2025-05-19 | 2025-09-19 | 86d | 45d | 0d |  |  | Participants | Participants | 213.33 | 5.24 | Laura Kennedy | Green | GREEN |  |  |
| 1691 | 1.6.2.6.3 | Completion of Code Bodies review of Final QAD (Non-MVC) |  | 25d | 2025-09-22 | 2025-10-24 | 1690 |  |  | 2025-09-22 | 2025-10-24 | 19d | 45d | 20d |  |  | Code Bodies | Code Bodies | 339.33 | 5.24 | Laura Kennedy | Green | GREEN |  |  |
| 1692 | 1.6.2.6.4 | QAD Sign Off Deadline (Non-MVC) |  | 1d | 2025-11-28 | 2025-11-28 | 1691FS+4d, 1378 |  |  | 2025-11-28 | 2025-11-28 | 1d | 25d | 0d |  |  | Participants | Participants | 406.33 | 5.24 | Laura Kennedy | Green | GREEN |  |  |
| 1693 | 1.6.2.6.5 | REC Code Manager / BSC PAB Approval of Qualification (Non-MVC) | milestone | 0d | 2025-12-22 | 2025-12-22 | 1692FS+16d |  |  | 2025-12-22 | 2025-12-22 | 0d | 25d | 0d |  |  | Code Bodies | Code Bodies | 430.71 | 5.25 | Laura Kennedy | Green | AMBER | T3-QU-0086 | QAG |
| 1694 | 1.6.3 | **MHHS Qualification - Non-SIT LDSO** |  | 179d | 2025-01-06 | 2025-09-11 |  |  |  | 2025-01-06 | 2025-09-11 | 115d | 71d |  |  | -0 | N/A | N/A | -133.67 | 5.24 | N/A |  |  |  |  |
| 1695 | 1.6.3.1 | Initial QAD Submission window opens | milestone | 0d | 2025-01-06 | 2025-01-06 | 1670FS+96d |  |  | 2025-01-06 | 2025-01-06 | 0d | 773d |  |  |  | Participants | Participants | 80.71 | 5.24 | Laura Kennedy | Green | GREEN |  |  |
| 1696 | 1.6.3.2 | Non-SIT LDSO Participants submit initial QAD |  | 30d | 2025-01-06 | 2025-02-14 |  |  |  | 2025-01-06 | 2025-02-14 | 29d | 71d | 0d | start no earlier than 2025-01-06 |  | Participants | Participants | 80.33 | 5.24 | Laura Kennedy | Green | GREEN |  |  |
| 1697 | 1.6.3.3 | Non-SIT LDSO QT Participants have submitted their initial QAD | milestone | 0d | 2025-02-14 | 2025-02-14 | 1696 |  |  | 2025-02-14 | 2025-02-14 | 0d | 71d | 0d |  |  | Participants | Participants | 119.71 | 5.25 | Laura Kennedy | Green | GREEN | T3-QU-0087 | QAG |
| 1698 | 1.6.3.4 | Code Bodies review of Non-SIT LDSO participants Initial QAD |  | 35d | 2025-02-17 | 2025-04-04 | 1697 |  |  | 2025-02-17 | 2025-04-04 | 36d | 71d | 0d |  |  | Code Bodies | Code Bodies | 122.33 | 5.24 | Laura Kennedy | Green | GREEN |  |  |
| 1699 | 1.6.3.5 | Completion of Code Bodies review of Initial QAD | milestone | 0d | 2025-04-04 | 2025-04-04 | 1698 |  |  | 2025-04-04 | 2025-04-04 | 0d | 71d | 0d |  |  | Code Bodies | Code Bodies | 168.71 | 5.24 | Laura Kennedy | Green | GREEN |  |  |
| 1700 | 1.6.3.6 | Final QAD Submission window opens | milestone | 0d | 2025-04-07 | 2025-04-07 | 1699FS+1d |  |  | 2025-04-07 | 2025-04-07 | 0d | 71d | 9d |  |  | Participants | Participants | 171.71 | 5.24 | Laura Kennedy | Green | GREEN |  |  |
| 1701 | 1.6.3.7 | Non-SIT LDSO Participants submit Final QAD |  | 25d | 2025-04-21 | 2025-05-23 | 1608SS, 1700SS |  |  | 2025-04-21 | 2025-05-23 | 26d | 62d | 0d |  |  | Participants | Participants | 185.33 | 5.24 | Laura Kennedy | Green | GREEN |  |  |
| 1702 | 1.6.3.8 | Non-SIT LDSO QT Participants have submitted their final QAD | milestone | 0d | 2025-05-23 | 2025-05-23 | 1701 |  |  | 2025-05-23 | 2025-05-23 | 0d | 62d | 0d |  |  | Participants | Participants | 217.71 | 5.25 | Laura Kennedy | Green | AMBER | T3-QU-0088 | QAG |
| 1703 | 1.6.3.9 | Completion of Code Bodies review of the Final QAD |  | 20d | 2025-05-26 | 2025-06-20 | 1702 |  |  | 2025-05-26 | 2025-06-20 | 19d | 62d | 40d |  |  | Code Bodies | Code Bodies | 220.33 | 5.24 | Laura Kennedy | Green | GREEN |  |  |
| 1704 | 1.6.3.10 | QAD Sign Off Deadline (Non-SIT LDSOs) | milestone | 0d | 2025-08-22 | 2025-08-22 | 1703FS+5d, 1356 |  |  | 2025-08-22 | 2025-08-22 | 1d | 22d | 0d |  |  | Participants | Participants | 308.71 | 5.24 | Laura Kennedy | Green | GREEN |  |  |
| 1705 | 1.6.3.11 | BSC PAB & REC Manager approval of Qualification for Non-SIT LDSOs (Start of Migration for Qualification Participants) | milestone | 0d | 2025-09-11 | 2025-09-11 | 1606, 1704FS+14d |  |  | 2025-09-11 | 2025-09-11 | 0d | 595d |  |  |  | Non-SIT LDSO | Non-SIT LDSO | 328.71 | 5.24 | Ben Wickins | Green | GREEN | T2-QU-0500 | QAG (Non-SIT LDSO) |
| 1706 | 1.6.4 | **MHHS Qualification - Qualification Waves** |  | 814d | 2023-12-18 A | 2027-01-28 |  | 29% | 574.25d | 2023-12-18 | 2027-01-28 | 574d | 235d |  |  | -0 | N/A | N/A | -131.67 | 5.24 | N/A |  |  |  |  |
| 1707 | 1.6.4.1 | **Qualification Wave Prep** |  | 530d | 2023-12-18 A | 2025-12-26 |  | 55% | 238.32d | 2023-12-18 | 2025-12-26 | 424d | 519d |  |  | -0 | N/A | N/A | -131.67 | 5.24 | N/A |  |  |  |  |
| 1708 | 1.6.4.1.1 | **Non-SIT Supplier and Agent Test Approach and Plan** |  | 119d | 2023-12-18 A | 2024-05-30 A |  | 100% |  | 2023-12-18 | 2024-05-30 | 118d |  |  |  | -0 | N/A | N/A | -133.67 | 5.24 | N/A |  |  |  |  |
| 1709 | 1.6.4.1.1.1 | Draft Non-SIT S&A Test Approach and Plan |  | 50d | 2023-12-18 A | 2024-02-23 A |  | 100% |  | 2023-12-18 | 2024-02-23 | 50d |  |  | finish no earlier than 2024-02-23 |  | Non-SIT S&A QT Test Team | Non-SIT S&A QT Test Team |  | 5.24 | Laura Kennedy | Complete | COMPLETE |  |  |
| 1710 | 1.6.4.1.1.2 | Internal Review of Non-SIT S&A Test Approach and Plan (Code Bodies and MHHSP) |  | 10d | 2024-02-26 A | 2024-03-08 A | 1709 | 100% |  | 2024-02-26 | 2024-03-08 | 10d |  |  |  |  | Code Bodies, SI Team, SRO | Code Bodies, SI Team, SRO |  | 5.24 | Laura Kennedy | Complete | COMPLETE |  |  |
| 1711 | 1.6.4.1.1.3 | Issue Non-SIT S&A Test Approach and Plan for Consultation |  | 15d | 2024-03-18 A | 2024-04-05 A | 1710 | 100% |  | 2024-03-18 | 2024-04-05 | 15d |  |  | start no earlier than 2024-03-18 |  | Participants | Participants |  | 5.24 | Laura Kennedy | Complete | COMPLETE |  |  |
| 1712 | 1.6.4.1.1.4 | Update Non-SIT S&A Test Approach and Plan Post-Consultation |  | 10d | 2024-04-08 A | 2024-04-19 A | 1711 | 100% |  | 2024-04-08 | 2024-04-19 | 10d |  |  |  |  | Non-SIT S&A QT Test Team | Non-SIT S&A QT Test Team |  | 5.24 | Laura Kennedy | Complete | COMPLETE |  |  |
| 1713 | 1.6.4.1.1.5 | QWG Endorsement of Non-SIT S&A Test Approach and Plan |  | 1d | 2024-05-14 A | 2024-05-14 A |  | 100% |  | 2024-05-14 | 2024-05-14 | 1d |  |  | finish no earlier than 2024-05-14 |  | Non-SIT S&A QT Test Team | Non-SIT S&A QT Test Team |  | 5.24 | Laura Kennedy | Complete | COMPLETE |  |  |
| 1714 | 1.6.4.1.1.6 | QAG Approval of Non-SIT S&A Test Approach and Plan | milestone | 0d | 2024-05-23 A | 2024-05-23 A | 1713FS+7d | 100% |  | 2024-05-23 | 2024-05-23 | 0d |  |  |  |  | Non-SIT S&A QT Test Team | Non-SIT S&A QT Test Team |  | 5.25 | Laura Kennedy | Complete | COMPLETE | T3-QU-0089 | QAG |
| 1715 | 1.6.4.1.1.7 | BSC & REC PAB Approval of Non-SIT S&A Test Approach and Plan | milestone | 0d | 2024-05-30 A | 2024-05-30 A | 1714FS+5d | 100% |  | 2024-05-30 | 2024-05-30 | 0d |  |  |  |  | Code Bodies | Code Bodies |  | 5.25 | Laura Kennedy | Complete | COMPLETE | T3-QU-0090 | QAG |

Notes:
- 1689: 25/09/24 - Forecast has moved to 07/04/25, this will be baseliend once CR55 is approved.
- 1693: 6/8/24: Date at risk from scenario planning activity
- 1695: 25/09/24 - Forecast has moved to 06/01/25, this will be baseliend once CR55 is approved.
- 1696: 25/09/24 - Forecast has moved to 13/02/25, this will be baseliend once CR55 is approved.
- 1697: 28/08/24 - Date will be missed because the date for the initial QAD submission window has been moved back to reflect the delay to SIT activities and to provide Programme PPs with more time to prepare. Milestone date change was approved at QAG on 22/08/24, from 10/10/24 to 10/11/24. To go to 19/09/24 QAG for noting.
- 1698: 25/09/24 - Forecast has moved to 04/04/25, this will be baseliend once CR55 is approved.
- 1699: 25/09/24 - Forecast has moved to 04/04/25, this will be baseliend once CR55 is approved.
- 1700: 25/09/24 - Forecast has moved to 07/04/25, this will be baseliend once CR55 is approved.
- 1702: 6/8/24: Date at risk from scenario planning activity
- 1704: 18/09/24 - Adding dependency so the milestone is dependent on SIT LDSO MVC.
- 1705: 13/5: name changed as part of cr47.

| ID | WBS | Task | Type | Duration | Start | Finish | Predecessors | Complete | Baseline start | Baseline finish | Baseline duration | Total slack | Free slack | Constraint | Baseline cost | Responsible | Involved | Task Status | Update Version | MHHS Resource Name | Sched Status | RAG | Milestone ID | Text29 |
| --- | --- | --- | --- | --- | --- | --- | --- | --- | --- | --- | --- | --- | --- | --- | --- | --- | --- | --- | --- | --- | --- | --- | --- | --- |
| 1716 | 1.6.4.1.2 | **QT Test Data Approach and Plan** |  | 64d | 2024-04-19 A | 2024-07-18 A |  | 100% | 2024-04-19 | 2024-07-18 | 64d |  |  |  | -0 | N/A | N/A | -133.67 | 5.24 | N/A |  |  |  |  |
| 1717 | 1.6.4.1.2.1 | QT Test Data Approach agreed as part of the Non-SIT Supplier and Agent Test Approach and Plan | milestone | 0d | 2024-04-19 A | 2024-04-19 A | 1712 | 100% | 2024-04-19 | 2024-04-19 | 0d |  |  |  |  | Non-SIT S&A QT Test Team, Participants | Non-SIT S&A QT Test Team, Participants |  | 5.24 | Laura Kennedy | Complete | COMPLETE |  |  |
| 1718 | 1.6.4.1.2.2 | Draft Test Data Approach and Plan for QT |  | 10d | 2024-05-06 A | 2024-05-17 A | 1717 | 100% | 2024-05-06 | 2024-05-17 | 10d |  |  |  |  | Non-SIT S&A QT Test Team | Non-SIT S&A QT Test Team |  | 5.24 | Laura Kennedy | Complete | COMPLETE |  |  |
| 1719 | 1.6.4.1.2.3 | Internal Review (Code Bodies and MHHSP) of QT Test Data Approach and Plan |  | 15d | 2024-05-20 A | 2024-06-07 A | 1718 | 100% | 2024-05-20 | 2024-06-07 | 10d |  |  |  |  | Code Bodies, SI Team, SRO | Code Bodies, SI Team, SRO |  | 5.24 | Laura Kennedy | Complete | COMPLETE |  |  |
| 1720 | 1.6.4.1.2.4 | Issue QT Test Data Approach and Plan for Industry Consultation |  | 10d | 2024-06-10 A | 2024-06-21 A | 1719 | 100% | 2024-06-10 | 2024-06-21 | 10d |  |  |  |  | Participants | Participants |  | 5.24 | Laura Kennedy | Complete | COMPLETE |  |  |
| 1721 | 1.6.4.1.2.5 | Update QT Test Approach and Plan Post Industry Consultation |  | 5d | 2024-06-24 A | 2024-06-28 A | 1720 | 100% | 2024-06-24 | 2024-06-28 | 10d |  |  |  |  | Non-SIT S&A QT Team | Non-SIT S&A QT Team |  | 5.24 | Laura Kennedy | Complete | COMPLETE |  |  |
| 1722 | 1.6.4.1.2.6 | QWG Endorsement of Test Data Approach and Plan |  | 1d | 2024-07-09 A | 2024-07-09 A | 1721FS+6d | 100% | 2024-07-09 | 2024-07-09 | 1d |  |  |  |  | Non-SIT S&A QT Test Team | Non-SIT S&A QT Test Team |  | 5.24 | Laura Kennedy | Complete | COMPLETE |  |  |
| 1723 | 1.6.4.1.2.7 | QAG Approval of QT Test Data Approach and Plan | milestone | 0d | 2024-07-18 A | 2024-07-18 A | 1722FS+7d | 100% | 2024-07-18 | 2024-07-18 | 0d |  |  |  |  | Non-SIT S&A QT Test Team | Non-SIT S&A QT Test Team |  | 5.29 | Laura Kennedy | Complete | COMPLETE | T3-QU-0091 | QAG |
| 1724 | 1.6.4.1.3 | **QT Functional Test Scenarios and Test Cases** |  | 59d | 2024-03-04 A | 2024-05-23 A |  | 100% | 2024-03-04 | 2024-05-23 | 59d |  |  |  | -0 | N/A | N/A | -133.67 | 5.24 | N/A |  |  |  |  |
| 1725 | 1.6.4.1.3.1 | Draft Test Scenarios and Test Case list - Batch 1 |  | 10d | 2024-03-04 A | 2024-03-15 A |  | 100% | 2024-03-04 | 2024-03-15 | 10d |  |  | finish no earlier than 2024-03-15 |  | Non-SIT S&A QT Test Team, Code Bodies | Non-SIT S&A QT Test Team, Code Bodies |  | 5.24 | Laura Kennedy | Complete | COMPLETE |  |  |
| 1726 | 1.6.4.1.3.2 | Issue Batch 1 for Consultation |  | 15d | 2024-03-18 A | 2024-04-05 A | 1725 | 100% | 2024-03-18 | 2024-04-05 | 15d |  |  | start no earlier than 2024-03-18 |  | Participants | Participants |  | 5.24 | Laura Kennedy | Complete | COMPLETE |  |  |
| 1727 | 1.6.4.1.3.3 | Gap analysis against QT Requirements |  | 8d | 2024-03-18 A | 2024-03-27 A | 1725 | 100% | 2024-03-18 | 2024-03-27 | 8d |  |  |  |  | Non-SIT S&A QT Test Team | Non-SIT S&A QT Test Team |  | 5.24 | Laura Kennedy | Complete | COMPLETE |  |  |
| 1728 | 1.6.4.1.3.4 | Update Test Scenarios and Test Case list - Batch 2 |  | 6d | 2024-03-28 A | 2024-04-04 A | 1727 | 100% | 2024-03-28 | 2024-04-04 | 6d |  |  |  |  | Non-SIT S&A QT Test Team, Code Bodies | Non-SIT S&A QT Test Team, Code Bodies |  | 5.24 | Laura Kennedy | Complete | COMPLETE |  |  |
| 1729 | 1.6.4.1.3.5 | Issue Batch 2 for consultation |  | 10d | 2024-04-05 A | 2024-04-18 A | 1728 | 100% | 2024-04-05 | 2024-04-18 | 10d |  |  |  |  | Participants | Participants |  | 5.24 | Laura Kennedy | Complete | COMPLETE |  |  |
| 1730 | 1.6.4.1.3.6 | Update Batch 2 post consultation |  | 10d | 2024-04-19 A | 2024-05-02 A | 1729 | 100% | 2024-04-19 | 2024-05-02 | 10d |  |  |  |  | Non-SIT S&A QT Test Team, Code Bodies | Non-SIT S&A QT Test Team, Code Bodies |  | 5.24 | Laura Kennedy | Complete | COMPLETE |  |  |
| 1731 | 1.6.4.1.3.7 | QWG Endorsement of Batch 1 and 2 |  | 1d | 2024-05-14 A | 2024-05-14 A |  | 100% | 2024-05-14 | 2024-05-14 | 1d |  |  | finish no earlier than 2024-05-14 |  | Non-SIT S&A QT Test Team | Non-SIT S&A QT Test Team, Code Bodies, Participants |  | 5.24 | Laura Kennedy | Complete | COMPLETE |  |  |
| 1732 | 1.6.4.1.3.8 | QAG Approval of QT Functional Test Scenarios and Test Cases Batches 1 and 2 | milestone | 0d | 2024-05-23 A | 2024-05-23 A | 1731FS+7d | 100% | 2024-05-23 | 2024-05-23 | 0d |  |  |  |  | Non-SIT S&A QT Test Team | Non-SIT S&A QT Test Team, Code Bodies, Participants |  | 5.25 | Laura Kennedy | Complete | COMPLETE | T3-QU-0092 | QAG |
| 1733 | 1.6.4.1.4 | **QT Migration Test Scenarios and Test Cases** |  | 54d | 2024-05-06 A | 2024-07-18 A |  | 100% | 2024-05-06 | 2024-07-18 | 54d |  |  |  |  | N/A | N/A |  | 5.25 | N/A |  |  |  |  |
| 1734 | 1.6.4.1.4.1 | Draft Test Scenarios and Test Case list - Batch 1 |  | 20d | 2024-05-06 A | 2024-05-31 A | 982FS+12d | 100% | 2024-05-06 | 2024-05-31 | 20d |  |  |  |  | Non-SIT S&A QT Test Team, Code Bodies | Non-SIT S&A QT Test Team, Code Bodies |  | 5.25 | Laura Kennedy | Complete | COMPLETE |  |  |
| 1735 | 1.6.4.1.4.2 | Issue Batch 1 for Consultation |  | 10d | 2024-06-03 A | 2024-06-14 A | 1734 | 100% | 2024-06-03 | 2024-06-14 | 10d |  |  |  |  | Participants | Participants |  | 5.25 | Laura Kennedy | Complete | COMPLETE |  |  |
| 1736 | 1.6.4.1.4.3 | Update Batch 1 Post Consultation |  | 10d | 2024-06-17 A | 2024-06-28 A | 1735 | 100% | 2024-06-17 | 2024-06-28 | 10d |  |  |  |  | Non-SIT S&A QT Test Team | Non-SIT S&A QT Test Team |  | 5.25 | Laura Kennedy | Complete | COMPLETE |  |  |
| 1737 | 1.6.4.1.4.4 | QWG Endorsement of Batch 1 | milestone | 0d | 2024-07-09 A | 2024-07-09 A | 1736FS+7d | 100% | 2024-07-09 | 2024-07-09 | 0d |  |  |  |  | Non-SIT S&A QT Test Team | Non-SIT S&A QT Test Team, Code Bodies, Participants |  | 5.25 | Laura Kennedy | Complete | COMPLETE |  |  |
| 1738 | 1.6.4.1.4.5 | QAG Approval of QT Migration Test Scenarios and Test Cases Batches 1 | milestone | 0d | 2024-07-18 A | 2024-07-18 A | 1737FS+7d | 100% | 2024-07-18 | 2024-07-18 | 0d |  |  |  |  | Non-SIT S&A QT Test Team | Non-SIT S&A QT Test Team, Code Bodies, Participants |  | 5.29 | Laura Kennedy | Complete | COMPLETE | T3-QU-0119 | QAG |
| 1739 | 1.6.4.1.5 | **QT Non-Functional Test Scenarios and Test Cases** |  | 61d | 2024-09-20 | 2024-12-13 |  |  | 2024-09-20 | 2024-12-13 | 43d | 775d |  |  |  | N/A | N/A |  | 5.25 | N/A |  |  |  |  |
| 1740 | 1.6.4.1.5.1 | Draft Test Scenarios and Test Case list - Batch 2 |  | 27d | 2024-09-20 | 2024-10-28 | 1043FS+2d, 1037FS+2d |  | 2024-09-20 | 2024-10-28 | 10d | 775d | 0d |  |  | Non-SIT S&A QT Test Team, Code Bodies | Non-SIT S&A QT Test Team, Code Bodies | -27.67 | 5.25 | Laura Kennedy | Green | GREEN |  |  |
| 1741 | 1.6.4.1.5.2 | Issue Batch 2 for Consultation |  | 10d | 2024-10-29 | 2024-11-11 | 1740 |  | 2024-10-29 | 2024-11-11 | 10d | 775d | 0d |  |  | Participants | Participants | 11.33 | 5.25 | Laura Kennedy | Green | GREEN |  |  |
| 1742 | 1.6.4.1.5.3 | Update Batch 2 Post Consultation |  | 10d | 2024-11-12 | 2024-11-25 | 1741 |  | 2024-11-12 | 2024-11-25 | 10d | 775d | 0d |  |  | Non-SIT S&A QT Test Team | Non-SIT S&A QT Test Team | 25.33 | 5.25 | Laura Kennedy | Green | GREEN |  |  |
| 1743 | 1.6.4.1.5.4 | QWG Endorsement of Batch 2 | milestone | 0d | 2024-12-04 | 2024-12-04 | 1742FS+7d, 1643 |  | 2024-12-04 | 2024-12-04 | 0d | 775d | 0d |  |  | Non-SIT S&A QT Test Team | Non-SIT S&A QT Test Team, Code Bodies, Participants | 47.71 | 5.25 | Laura Kennedy | Green | GREEN |  |  |
| 1744 | 1.6.4.1.5.5 | QAG Approval of QT Non-Functional Test Scenarios and Test Cases Batch 2 | milestone | 0d | 2024-12-13 | 2024-12-13 | 1743FS+7d |  | 2024-12-13 | 2024-12-13 | 0d | 775d | 13d |  |  | Non-SIT S&A QT Test Team | Non-SIT S&A QT Test Team, Code Bodies, Participants | 56.71 | 5.27 | Laura Kennedy | Green | AMBER | T3-QU-0120 | QAG |

Notes:
- 1740: 25/09/24 - Proposed that this is removed and replaced with a milestone for Batch 3 of Functional Tests, but this has not yet been confirmed.
- 1741: 25/09/24 - Proposed that this is removed and replaced with a milestone for Batch 3 of Functional Tests, but this has not yet been confirmed.
- 1742: 25/09/24 - Proposed that this is removed and replaced with a milestone for Batch 3 of Functional Tests, but this has not yet been confirmed.
- 1743: 25/09/24 - Proposed that this is removed and replaced with a milestone for Batch 3 of Functional Tests, but this has not yet been confirmed.
- 1744: 25/09/24 - Proposed that this is removed and replaced with a milestone for Batch 3 of Functional Tests, but this has not yet been confirmed.

| ID | WBS | Task | Type | Duration | Start | Finish | Predecessors | Complete | Remaining | Baseline start | Baseline finish | Baseline duration | Total slack | Free slack | Constraint | Baseline cost | Responsible | Involved | Update Version | MHHS Resource Name | Task Status | Sched Status | RAG | Milestone ID | Text29 |
| --- | --- | --- | --- | --- | --- | --- | --- | --- | --- | --- | --- | --- | --- | --- | --- | --- | --- | --- | --- | --- | --- | --- | --- | --- | --- |
| 1745 | 1.6.4.1.6 | **QT Operational Test Scenarios and Test Cases** |  | 82d | 2024-09-10 | 2025-01-01 |  |  |  | 2024-09-10 | 2025-01-01 | 63d | 762d |  |  |  | N/A | N/A | 5.25 | N/A |  |  |  |  |  |
| 1746 | 1.6.4.1.6.1 | Draft QT Operational Test Cases - Batch 1 |  | 47d | 2024-09-11 | 2024-11-14 | 1100FS+2d, 1723 |  |  | 2024-09-11 | 2024-11-14 | 10d | 762d | 0d |  |  | Non-SIT S&A QT Test Team, Code Bodies | Non-SIT S&A QT Test Team, Code Bodies | 5.25 | Laura Kennedy | -36.67 | Green | GREEN |  |  |
| 1747 | 1.6.4.1.6.2 | Issue Batch 1 for Consultation |  | 10d | 2024-11-15 | 2024-11-28 | 1746 |  |  | 2024-11-15 | 2024-11-28 | 10d | 762d | 0d |  |  | Participants | Participants | 5.25 | Laura Kennedy | 28.33 | Green | GREEN |  |  |
| 1748 | 1.6.4.1.6.3 | Update Batch 1 Post Consultation |  | 10d | 2024-11-29 | 2024-12-12 | 1747 |  |  | 2024-11-29 | 2024-12-12 | 10d | 762d | 0d |  |  | Non-SIT S&A QT Test Team | Non-SIT S&A QT Test Team | 5.25 | Laura Kennedy | 42.33 | Green | GREEN |  |  |
| 1749 | 1.6.4.1.6.4 | QWG Endorsement of Batch 1 | milestone | 0d | 2024-12-23 | 2024-12-23 | 1748FS+7d |  |  | 2024-12-23 | 2024-12-23 | 0d | 762d | 0d |  |  | Non-SIT S&A QT Test Team | Non-SIT S&A QT Test Team, Code Bodies, Participants | 5.25 | Laura Kennedy | 66.71 | Green | GREEN |  |  |
| 1750 | 1.6.4.1.6.5 | QAG Approval of QT Operational Test Scenarios and Test Cases Batch 1 | milestone | 0d | 2025-01-01 | 2025-01-01 | 1749FS+7d |  |  | 2025-01-01 | 2025-01-01 | 0d | 762d | 0d |  |  | Non-SIT S&A QT Test Team | Non-SIT S&A QT Test Team, Code Bodies, Participants | 5.27 | Laura Kennedy | 75.71 | Green | AMBER | T3-QU-0121 | QAG |
| 1751 | 1.6.4.1.6.6 | Draft QT Operational Test Cases - Batch 2 |  | 10d | 2024-09-10 | 2024-09-23 | 1106FS+2d |  |  | 2024-09-10 | 2024-09-23 | 10d | 800d | 0d |  |  | Non-SIT S&A QT Test Team, Code Bodies | Non-SIT S&A QT Test Team, Code Bodies | 5.25 | Laura Kennedy | -37.67 | Green | GREEN |  |  |
| 1752 | 1.6.4.1.6.7 | Issue Batch 2 for Consultation |  | 10d | 2024-09-24 | 2024-10-07 | 1751 |  |  | 2024-09-24 | 2024-10-07 | 10d | 800d | 0d |  |  | Participants | Participants | 5.25 | Laura Kennedy | -23.67 | Green | GREEN |  |  |
| 1753 | 1.6.4.1.6.8 | Update Batch 2 Post Consultation |  | 10d | 2024-10-08 | 2024-10-21 | 1752 |  |  | 2024-10-08 | 2024-10-21 | 10d | 800d | 0d |  |  | Non-SIT S&A QT Test Team | Non-SIT S&A QT Test Team | 5.25 | Laura Kennedy | -9.67 | Green | GREEN |  |  |
| 1754 | 1.6.4.1.6.9 | QWG Endorsement of Batch 2 | milestone | 0d | 2024-10-30 | 2024-10-30 | 1753FS+7d |  |  | 2024-10-30 | 2024-10-30 | 0d | 800d | 0d |  |  | Non-SIT S&A QT Test Team | Non-SIT S&A QT Test Team, Code Bodies, Participants | 5.25 | Laura Kennedy | 12.71 | Green | GREEN |  |  |
| 1755 | 1.6.4.1.6.10 | QAG Approval of QT Operational Test Scenarios and Test Cases Batch 2 | milestone | 0d | 2024-11-08 | 2024-11-08 | 1754FS+7d |  |  | 2024-11-08 | 2024-11-08 | 0d | 800d | 38d |  |  | Non-SIT S&A QT Test Team | Non-SIT S&A QT Test Team, Code Bodies, Participants | 5.27 | Laura Kennedy | 21.71 | Green | GREEN | T3-QU-0122 | QAG |
| 1756 | 1.6.4.1.7 | **Qualification Testing Framework (Test Stubs and Supporting UI)** |  | 500d | 2024-01-29 A | 2025-12-26 |  | 50% | 251.93d | 2024-01-29 | 2025-12-26 | 394d | 519d |  |  | -0 | N/A | N/A | 5.27 | N/A | -594.67 |  |  |  |  |
| 1757 | 1.6.4.1.7.1 | Proof of Concept for QTF Completion |  | 45d | 2024-01-29 A | 2024-03-29 A |  | 100% |  | 2024-01-29 | 2024-03-29 | 45d |  |  | start no earlier than 2024-01-22 |  | Non-SIT S&A QT Test Team | Non-SIT S&A QT Test Team | 5.27 | Laura Kennedy |  | Complete | COMPLETE |  |  |
| 1758 | 1.6.4.1.7.2 | Discovery and Mobilisation |  | 25d | 2024-04-01 A | 2024-05-03 A | 1757 | 100% |  | 2024-04-01 | 2024-05-03 | 25d |  |  |  |  | Non-SIT S&A QT Test Team | Non-SIT S&A QT Test Team | 5.27 | Laura Kennedy |  | Complete | COMPLETE |  |  |
| 1759 | 1.6.4.1.7.3 | **Agile DBT of Qualification Testing Framework** |  | 83d | 2024-04-24 A | 2024-08-16 A |  | 100% |  | 2024-04-24 | 2024-08-16 | 83d |  |  |  | -0 | N/A | N/A | 5.27 | N/A |  |  |  |  |  |
| 1760 | 1.6.4.1.7.3.1 | **User Interface (UI)** |  | 48d | 2024-04-24 A | 2024-06-28 A |  | 100% |  | 2024-04-24 | 2024-06-28 | 48d |  |  |  |  | N/A | N/A | 5.27 | N/A | -594.67 |  |  |  |  |
| 1761 | 1.6.4.1.7.3.1.1 | UI Wireframe |  | 48d | 2024-04-24 A | 2024-06-28 A | 1712FS+2d | 100% |  | 2024-04-24 | 2024-06-28 | 48d |  |  |  |  | Non-SIT S&A QT Test Team | Non-SIT S&A QT Test Team | 5.27 | Laura Kennedy |  | Complete | COMPLETE |  |  |
| 1762 | 1.6.4.1.7.3.1.2 | UI Standards |  | 35d | 2024-05-13 A | 2024-06-28 A | 1761SS+13d | 100% |  | 2024-05-13 | 2024-06-28 | 35d |  |  |  |  | Non-SIT S&A QT Test Team | Non-SIT S&A QT Test Team | 5.27 | Laura Kennedy |  | Complete | COMPLETE |  |  |
| 1763 | 1.6.4.1.7.3.1.3 | Elexon Branding Sylesheet |  | 1d | 2024-05-17 A | 2024-05-20 A | 1758FS+10d | 100% |  | 2024-05-17 | 2024-05-20 | 1d |  |  |  |  | Non-SIT S&A QT Test Team | Non-SIT S&A QT Test Team | 5.27 | Laura Kennedy |  | Complete | COMPLETE |  |  |
| 1764 | 1.6.4.1.7.3.1.4 | Elexon Branding QTF Logo |  | 1d | 2024-05-31 A | 2024-06-03 A | 1758FS+20d | 100% |  | 2024-05-31 | 2024-06-03 | 1d |  |  |  |  | Non-SIT S&A QT Test Team | Non-SIT S&A QT Test Team | 5.27 | Laura Kennedy |  | Complete | COMPLETE |  |  |
| 1765 | 1.6.4.1.7.3.2 | **Design, Build, Test** |  | 70d | 2024-05-13 A | 2024-08-16 A |  | 100% |  | 2024-05-13 | 2024-08-16 | 70d |  |  |  |  | N/A | N/A | 5.27 | N/A | -594.67 |  |  |  |  |
| 1766 | 1.6.4.1.7.3.2.1 | Core UI Screens |  | 60d | 2024-05-13 A | 2024-08-02 A | 1762SS | 100% |  | 2024-05-13 | 2024-08-02 | 60d |  |  |  |  | Non-SIT S&A QT Test Team | Non-SIT S&A QT Test Team | 5.27 | Laura Kennedy |  | Complete | COMPLETE |  |  |
| 1767 | 1.6.4.1.7.3.2.2 | Tooling (Trigger Files / Template Generators) |  | 70d | 2024-05-13 A | 2024-08-16 A | 1761SS+13d | 100% |  | 2024-05-13 | 2024-08-16 | 70d |  |  |  |  | Non-SIT S&A QT Test Team | Non-SIT S&A QT Test Team | 5.27 | Laura Kennedy |  | Complete | COMPLETE |  |  |
| 1768 | 1.6.4.1.7.3.2.3 | Database Schema |  | 50d | 2024-05-13 A | 2024-07-19 A | 1761SS+13d | 100% |  | 2024-05-13 | 2024-07-19 | 50d |  |  |  |  | Non-SIT S&A QT Test Team | Non-SIT S&A QT Test Team | 5.27 | Laura Kennedy |  | Complete | COMPLETE |  |  |
| 1769 | 1.6.4.1.7.3.2.4 | Core API's |  | 60d | 2024-05-13 A | 2024-08-02 A | 1761SS+13d | 100% |  | 2024-05-13 | 2024-08-02 | 60d |  |  |  |  | Non-SIT S&A QT Test Team | Non-SIT S&A QT Test Team | 5.27 | Laura Kennedy |  | Complete | COMPLETE |  |  |
| 1770 | 1.6.4.1.7.3.2.5 | DIP (SIT-A) Onboarding for Development inc. Test Stubs |  | 1d | 2024-07-12 A | 2024-07-12 A | 1758FS+49d | 100% |  | 2024-07-12 | 2024-07-12 | 1d |  |  |  |  | Non-SIT S&A QT Test Team, Electralink | Non-SIT S&A QT Test Team, Electralink | 5.27 | Laura Kennedy |  | Complete | COMPLETE |  |  |
| 1771 | 1.6.4.1.7.3.2.6 | DTN Onboarding for Development inc. Test Stubs |  | 1d | 2024-07-15 A | 2024-07-15 A | 1770 | 100% |  | 2024-07-15 | 2024-07-15 | 1d |  |  |  |  | Non-SIT S&A QT Test Team, MHHSP, Avanade | Non-SIT S&A QT Test Team, MHHSP, Avanade | 5.27 | Laura Kennedy |  | Complete | COMPLETE |  |  |
| 1772 | 1.6.4.1.7.4 | QTF Test Cases DBT Refinement, Execution and Results Validation, Defect Management, Error Handling |  | 131d | 2024-07-03 | 2025-01-01 | 1738FF, 1744FF, 1750FF, 1755FF |  |  | 2024-07-03 | 2025-01-01 | 79d | 762d | 0d |  |  | Non-SIT S&A QT Test Team | Non-SIT S&A QT Test Team | 5.27 | Laura Kennedy | -106.67 | Overdue Start | GREEN |  |  |

Notes:
- 1745: Impact: QT Test Scenarios which reuse SIT Scenarios are unable to be approved until SIT Scenarios are approved.
- 1746: 25/09/24 - Proposed that this is removed and replaced with a milestone for Batch 3 of Functional Tests, but this has not yet been confirmed. / Action: 9/7/24: Potential delay as delay from the test side. Does it need to be linked to all 3 or just 1?
- 1747: 25/09/24 - Proposed that this is removed and replaced with a milestone for Batch 3 of Functional Tests, but this has not yet been confirmed.
- 1748: 25/09/24 - Proposed that this is removed and replaced with a milestone for Batch 3 of Functional Tests, but this has not yet been confirmed.
- 1749: 25/09/24 - Proposed that this is removed and replaced with a milestone for Batch 3 of Functional Tests, but this has not yet been confirmed.
- 1750: 25/09/24 - Proposed that this is removed and replaced with a milestone for Batch 3 of Functional Tests, but this has not yet been confirmed.
- 1751: 25/09/24 - Proposed that this is removed and replaced with a milestone for Batch 3 of Functional Tests, but this has not yet been confirmed.
- 1752: 25/09/24 - Proposed that this is removed and replaced with a milestone for Batch 3 of Functional Tests, but this has not yet been confirmed.
- 1753: 25/09/24 - Proposed that this is removed and replaced with a milestone for Batch 3 of Functional Tests, but this has not yet been confirmed.
- 1754: 25/09/24 - Proposed that this is removed and replaced with a milestone for Batch 3 of Functional Tests, but this has not yet been confirmed.
- 1755: 25/09/24 - Proposed that this is removed and replaced with a milestone for Batch 3 of Functional Tests, but this has not yet been confirmed.

| ID | WBS | Task | Duration | Start | Finish | Predecessors | Complete | Remaining | Baseline start | Baseline finish | Baseline duration | Total slack | Free slack | Constraint | Baseline cost | Responsible | Involved | Task Status | Update Version | MHHS Resource Name | Sched Status | RAG | Action |
| --- | --- | --- | --- | --- | --- | --- | --- | --- | --- | --- | --- | --- | --- | --- | --- | --- | --- | --- | --- | --- | --- | --- | --- |
| 1773 | 1.6.4.1.7.5 | **Environments** | 202d | 2024-04-15 A | 2025-01-21 |  | 54% | 93.15d | 2024-04-15 | 2025-01-21 | 158d | 762d |  |  | -0 | N/A | N/A | -594.67 | 5.27 | N/A |  |  |  |
| 1774 | 1.6.4.1.7.5.1 | **Azure Devops** | 120d | 2024-04-15 A | 2024-09-27 |  | 42% | 69.38d | 2024-04-15 | 2024-09-27 | 120d | 216d |  |  | -0 | N/A | N/A | -594.67 | 5.27 | N/A |  |  |  |
| 1775 | 1.6.4.1.7.5.1.1 | **QFT ADO Development Instance** | 15d | 2024-04-15 A | 2024-05-03 A |  | 100% |  | 2024-04-15 | 2024-05-03 | 15d |  |  |  |  | N/A | N/A | -594.67 | 5.27 | N/A |  |  |  |
| 1776 | 1.6.4.1.7.5.1.1.1 | Elexon Instance Setup for QTF Build | 5d | 2024-04-15 A | 2024-04-19 A | 1758SS+10d | 100% |  | 2024-04-15 | 2024-04-19 | 5d |  |  |  |  | Non-SIT S&A QT Test Team | Non-SIT S&A QT Test Team |  | 5.27 | Laura Kennedy | Complete | COMPLETE |  |
| 1777 | 1.6.4.1.7.5.1.1.2 | Configuration and User Access | 10d | 2024-04-22 A | 2024-05-03 A | 1776 | 100% |  | 2024-04-22 | 2024-05-03 | 10d |  |  |  |  | Non-SIT S&A QT Test Team | Non-SIT S&A QT Test Team |  | 5.27 | Laura Kennedy | Complete | COMPLETE |  |
| 1778 | 1.6.4.1.7.5.1.2 | **MHHSP ADO Instance** | 49d | 2024-07-23 A | 2024-09-27 |  | 24% | 37d | 2024-07-23 | 2024-09-27 | 50d | 216d |  |  |  | N/A | N/A | -594.67 | 5.27 | N/A | Complete |  |  |
| 1779 | 1.6.4.1.7.5.1.2.1 | MHHSP Instance Setup for QTF Production | 29d | 2024-07-23 A | 2024-08-30 | 1785SS+41d | 41% | 17d | 2024-07-23 | 2024-08-30 | 30d | 216d | 0d |  |  | MHHSP | MHHSP |  | 5.27 | Laura Kennedy | Green | GREEN |  |
| 1780 | 1.6.4.1.7.5.1.2.2 | Configuration and User Access | 20d | 2024-09-02 | 2024-09-27 | 1779, 1836 |  |  | 2024-09-02 | 2024-09-27 | 20d | 216d | 175d |  |  | Non-SIT S&A QT Test Team | Non-SIT S&A QT Test Team | -45.67 | 5.27 | Laura Kennedy | Green | GREEN |  |
| 1781 | 1.6.4.1.7.5.2 | **Temporary Development Environment** | 35d | 2024-04-15 A | 2024-05-31 A |  | 100% |  | 2024-04-15 | 2024-05-31 | 35d |  |  |  |  | N/A | N/A | -594.67 | 5.27 | N/A |  |  |  |
| 1782 | 1.6.4.1.7.5.2.1 | Design | 15d | 2024-04-15 A | 2024-05-03 A | 1758SS+10d | 100% |  | 2024-04-15 | 2024-05-03 | 15d |  |  |  |  | Non-SIT S&A QT Test Team | Non-SIT S&A QT Test Team |  | 5.27 | Laura Kennedy | Complete | COMPLETE |  |
| 1783 | 1.6.4.1.7.5.2.2 | Build and Deployment | 20d | 2024-05-06 A | 2024-05-31 A | 1777, 1782 | 100% |  | 2024-05-06 | 2024-05-31 | 20d |  |  |  |  | Non-SIT S&A QT Test Team | Non-SIT S&A QT Test Team |  | 5.27 | Laura Kennedy | Complete | COMPLETE |  |
| 1784 | 1.6.4.1.7.5.3 | **Dev, Test & Prod Environment Requirements + Design** | 105d | 2024-05-27 A | 2024-10-18 |  | 58% | 43.91d | 2024-05-27 | 2024-10-18 | 105d | 829d |  |  | -0 | N/A | N/A | -594.67 | 5.27 | N/A |  |  |  |
| 1785 | 1.6.4.1.7.5.3.1 | Design (including Security Review) | 70d | 2024-05-27 A | 2024-08-30 | 1758FS+15d | 76% | 17d | 2024-05-27 | 2024-08-30 | 70d | 864d | 0d |  |  | Non-SIT S&A QT Test Team | Non-SIT S&A QT Test Team |  | 5.27 | Laura Kennedy | Green | GREEN |  |
| 1786 | 1.6.4.1.7.5.3.2 | Hub Deployment | 20d | 2024-06-10 A | 2024-07-05 A | 1785SS+10d | 100% |  | 2024-06-10 | 2024-07-05 | 20d |  |  |  |  | Non-SIT S&A QT Test Team | Non-SIT S&A QT Test Team |  | 5.27 | Laura Kennedy | Complete | COMPLETE |  |
| 1787 | 1.6.4.1.7.5.3.3 | Development Envn. Deployment | 40d | 2024-07-08 A | 2024-08-30 | 1786 | 58% | 17d | 2024-07-08 | 2024-08-30 | 40d | 815d | 0d |  |  | Non-SIT S&A QT Test Team | Non-SIT S&A QT Test Team |  | 5.27 | Laura Kennedy | Green | GREEN |  |
| 1788 | 1.6.4.1.7.5.3.4 | Test Envn. Deployment | 10d | 2024-09-02 | 2024-09-13 | 1787 |  |  | 2024-09-02 | 2024-09-13 | 10d | 815d | 0d |  |  | Non-SIT S&A QT Test Team | Non-SIT S&A QT Test Team | -45.67 | 5.27 | Laura Kennedy | Green | GREEN |  |
| 1789 | 1.6.4.1.7.5.3.5 | Production Envn. Deployment | 25d | 2024-09-16 | 2024-10-18 | 1788 |  |  | 2024-09-16 | 2024-10-18 | 25d | 815d | 53d |  |  | Non-SIT S&A QT Test Team | Non-SIT S&A QT Test Team | -31.67 | 5.27 | Laura Kennedy | Green | GREEN |  |
| 1790 | 1.6.4.1.7.5.4 | **QTF Deployment into Production** | 14d | 2025-01-02 | 2025-01-21 |  |  |  | 2025-01-02 | 2025-01-21 | 14d | 762d |  |  |  | N/A | N/A | -594.67 | 5.27 | N/A | No BL |  |  |
| 1791 | 1.6.4.1.7.5.4.1 | App Deployment | 1d | 2025-01-02 | 2025-01-02 | 1772, 1789 |  |  | 2025-01-02 | 2025-01-02 | 1d | 762d | 0d |  |  | Non-SIT S&A QT Test Team | Non-SIT S&A QT Test Team | 76.33 | 5.27 | Laura Kennedy | Green | GREEN |  |
| 1792 | 1.6.4.1.7.5.4.2 | Smoke Test | 2d | 2025-01-02 | 2025-01-03 | 1791SS |  |  | 2025-01-02 | 2025-01-03 | 2d | 762d | 0d |  |  | Non-SIT S&A QT Test Team | Non-SIT S&A QT Test Team | 76.33 | 5.27 | Laura Kennedy | Green | GREEN |  |
| 1793 | 1.6.4.1.7.5.4.3 | PEN Test | 2d | 2025-01-06 | 2025-01-07 | 1792 |  |  | 2025-01-06 | 2025-01-07 | 2d | 762d | 0d |  |  | Non-SIT S&A QT Test Team | Non-SIT S&A QT Test Team | 80.33 | 5.27 | Laura Kennedy | Green | GREEN |  |
| 1794 | 1.6.4.1.7.5.4.4 | Regression Test | 10d | 2025-01-08 | 2025-01-21 | 1793 |  |  | 2025-01-08 | 2025-01-21 | 10d | 762d |  |  |  | Non-SIT S&A QT Test Team | Non-SIT S&A QT Test Team | 82.33 | 5.27 | Laura Kennedy | Green | GREEN |  |
| 1795 | 1.6.4.1.7.5.5 | **DIP Onboarding (UIT)** | 37d | 2024-08-05 A | 2024-09-24 |  | 46% | 20d | 2024-08-05 | 2024-09-24 | 37d | 847d |  |  |  | N/A | N/A | -594.67 | 5.27 | N/A |  |  |  |
| 1796 | 1.6.4.1.7.5.5.1 | DIP available for Onboarding | 1d | 2024-08-05 A | 2024-08-05 A | 1782 | 100% |  | 2024-08-05 | 2024-08-05 | 1d |  |  | start no earlier than 2024-08-05 |  | MHHSP, Avanade | MHHSP, Avanade |  | 5.27 | Laura Kennedy | Complete | COMPLETE | 3/7: Link into UIT ENV |
| 1797 | 1.6.4.1.7.5.5.2 | Qualification Testing for Non-SIT S&A Participants' environments) Ready to start DIP onboarding (incl. certificates and security compliance) | 15d | 2024-08-06 A | 2024-08-26 A | 1796 | 100% |  | 2024-08-06 | 2024-08-26 | 15d |  |  |  |  | MHHSP, Avanade | MHHSP, Avanade |  | 5.27 | Laura Kennedy | Complete | COMPLETE |  |
| 1798 | 1.6.4.1.7.5.5.3 | Non-SIT S&A QTF Environments Connection Confirmed to UIT Environment | 1d | 2024-08-27 A | 2024-08-27 A | 1797 | 100% |  | 2024-08-27 | 2024-08-27 | 1d |  |  |  |  | Non-SIT S&A QT Test Team | Non-SIT S&A QT Test Team |  | 5.27 | Laura Kennedy | Complete | COMPLETE |  |
| 1799 | 1.6.4.1.7.5.5.4 | DIP UIT Test Stubs | 20d | 2024-08-28 | 2024-09-24 | 1798 |  |  | 2024-08-28 | 2024-09-24 | 20d | 847d |  |  |  | Non-SIT S&A QT Test Team | Non-SIT S&A QT Test Team, Avanade | -50.67 | 5.27 |  | Green | GREEN |  |

Notes:
- 1792: Team confirming when this should take place, expected that the forecast is too late.
- 1793: Team confirming when this should take place, expected that the forecast is too late.
- 1794: Team confirming when this should take place, expected that the forecast is too late.

| ID | WBS | Task | Duration | Start | Finish | Predecessors | Complete | Remaining | Baseline start | Baseline finish | Baseline duration | Total slack | Free slack | Constraint | Baseline cost | Responsible | Involved | Task Status | Update Version | MHHS Resource Name | Sched Status | RAG |
| --- | --- | --- | --- | --- | --- | --- | --- | --- | --- | --- | --- | --- | --- | --- | --- | --- | --- | --- | --- | --- | --- | --- |
| 1800 | 1.6.4.1.7.5.6 | **DTN Onboarding** | 95d | 2024-05-20 A | 2024-09-27 |  | 47% | 50.21d | 2024-05-20 | 2024-09-27 | 95d | 844d |  |  | -0 | N/A | N/A | -594.67 | 5.27 | N/A |  |  |
| 1801 | 1.6.4.1.7.5.6.1 | DTN Request Raised for Onboarding | 25d | 2024-05-20 A | 2024-06-21 A | 1782FS+10d | 100% |  | 2024-05-20 | 2024-06-21 | 25d |  |  |  |  | Non-SIT S&A QT Test Team | Non-SIT S&A QT Test Team |  | 5.27 | Laura Kennedy | Complete | COMPLETE |
| 1802 | 1.6.4.1.7.5.6.2 | Setup, configuration of New Host and Test Flags | 5d | 2024-06-24 A | 2024-06-28 A | 1801 | 100% |  | 2024-06-24 | 2024-06-28 | 5d |  |  |  |  | Electralink | Electralink |  | 5.27 | Laura Kennedy | Complete | COMPLETE |
| 1803 | 1.6.4.1.7.5.6.3 | New VPN Connection | 30d | 2024-08-05 A | 2024-09-13 | 1802FS+25d | 10% | 27d | 2024-08-05 | 2024-09-13 | 30d | 844d | 0d |  |  | QT Test Team | QT Test Team |  | 5.30 | Laura Kennedy | Green | GREEN |
| 1804 | 1.6.4.1.7.5.6.4 | DTN Test Stubs | 10d | 2024-09-16 | 2024-09-27 | 1803 |  |  | 2024-09-16 | 2024-09-27 | 10d | 844d |  |  |  | Non-SIT S&A QT Test Team | Non-SIT S&A QT Test Team | -31.67 | 5.27 | Laura Kennedy | Green | GREEN |
| 1805 | 1.6.4.1.7.6 | **Test Data (MPANs, DIP Messages, Settlement, Consumption, Reference)** | 405d | 2024-06-10 A | 2025-12-26 |  | 15% | 346.04d | 2024-06-10 | 2025-12-26 | 299d | 519d |  |  | -0 | N/A | N/A | -385.67 | 5.27 | N/A |  |  |
| 1806 | 1.6.4.1.7.6.1 | Sample MPAN Data + Attributes from Suppliers | 15d | 2024-06-10 A | 2024-06-28 A | 1719 | 100% |  | 2024-06-10 | 2024-06-28 | 15d |  |  |  |  | Participants | Participants |  | 5.27 | Laura Kennedy | Complete | COMPLETE |
| 1807 | 1.6.4.1.7.6.2 | Test Data Templates and generator tools ready | 30d | 2024-06-24 A | 2024-08-02 A | 1767SS+20d, 1806FF+25d | 100% |  | 2024-06-24 | 2024-08-02 | 30d |  |  |  |  | Non-SIT S&A QT Test Team | Non-SIT S&A QT Test Team |  | 5.27 | Laura Kennedy | Complete | COMPLETE |
| 1808 | 1.6.4.1.7.6.3 | **Industry Standing Data (ISD)** | 33d | 2024-07-26 A | 2024-09-10 |  | 6% | 31.17d | 2024-07-26 | 2024-09-10 | 33d | 857d |  |  | -0 | N/A | N/A | -594.67 | 5.27 | N/A |  |  |
| 1809 | 1.6.4.1.7.6.3.1 | Dependant on Receiving ISD Agreed Source Data from Helix | 1d | 2024-07-26 A | 2024-07-26 A |  | 100% |  | 2024-07-26 | 2024-07-26 | 1d |  |  | start no earlier than 2024-07-26 |  | Helix | Helix |  | 5.27 | Laura Kennedy | Complete | COMPLETE |
| 1810 | 1.6.4.1.7.6.3.2 | First View of Migrated ISD Data | 1d | 2024-08-19 | 2024-08-19 | 1809 |  |  | 2024-08-19 | 2024-08-19 | 1d | 857d | 0d | start no earlier than 2024-08-19 |  |  |  | -59.67 | 5.28 | Laura Kennedy | Overdue Start | RED |
| 1811 | 1.6.4.1.7.6.3.3 | Final Cycle 3 Migrated ISD Data | 1d | 2024-08-20 | 2024-08-20 | 1810 |  |  | 2024-08-20 | 2024-08-20 | 1d | 857d | 0d |  |  |  |  | -58.67 | 5.28 | Laura Kennedy | Overdue Start | RED |
| 1812 | 1.6.4.1.7.6.3.4 | Create ISD Template inc. DIP ID | 5d | 2024-08-21 | 2024-08-27 | 1811 |  |  | 2024-08-21 | 2024-08-27 | 5d | 857d | 0d |  |  | Non-SIT S&A QT Test Team | Non-SIT S&A QT Test Team | -57.67 | 5.27 | Laura Kennedy | Overdue Start | GREEN |
| 1813 | 1.6.4.1.7.6.3.5 | Publish Qualification ISD | 10d | 2024-08-28 | 2024-09-10 | 1812 |  |  | 2024-08-28 | 2024-09-10 | 10d | 857d |  |  |  | Non-SIT S&A QT Test Team | Non-SIT S&A QT Test Team | -50.67 | 5.27 | Laura Kennedy | Green | GREEN |
| 1814 | 1.6.4.1.7.6.4 | **Wave 1 Test Data** | 46d | 2025-05-12 | 2025-07-14 |  |  |  | 2025-05-12 | 2025-07-14 | 46d | 35d |  |  |  | N/A | N/A | -596.67 | 5.27 | N/A |  |  |
| 1815 | 1.6.4.1.7.6.4.1 | Test Data Request + Templates Completed | 16d | 2025-05-12 | 2025-06-02 | 1858 |  |  | 2025-05-12 | 2025-06-02 | 16d | 35d | 0d |  |  | Participants | Participants | 206.33 | 5.27 | Laura Kennedy | Green | GREEN |
| 1816 | 1.6.4.1.7.6.4.2 | Test Data Generated | 10d | 2025-06-03 | 2025-06-16 | 1815 |  |  | 2025-06-03 | 2025-06-16 | 10d | 35d | 0d |  |  | Non-SIT S&A QT Test Team | Non-SIT S&A QT Test Team | 228.33 | 5.27 | Laura Kennedy | Green | GREEN |
| 1817 | 1.6.4.1.7.6.4.3 | Test Data Loaded into QP Systems | 20d | 2025-06-17 | 2025-07-14 | 1816 |  |  | 2025-06-17 | 2025-07-14 | 20d | 35d | 0d |  |  | Participants | Participants | 242.33 | 5.27 | Laura Kennedy | Green | GREEN |
| 1818 | 1.6.4.1.7.6.4.4 | Test Data Loaded into QTF + ADO | 19d | 2025-06-17 | 2025-07-11 | 1816 |  |  | 2025-06-17 | 2025-07-11 | 20d | 36d | 1d |  |  | Non-SIT S&A QT Test Team | Non-SIT S&A QT Test Team | 242.33 | 5.27 | Laura Kennedy | Green | GREEN |
| 1819 | 1.6.4.1.7.6.5 | **Wave 2 Test Data** | 42d | 2025-07-07 | 2025-09-02 |  |  |  | 2025-07-07 | 2025-09-02 | 42d | 39d |  |  |  | N/A | N/A | -596.67 | 5.27 | N/A |  |  |
| 1820 | 1.6.4.1.7.6.5.1 | Test Data Request + Templates Completed | 16d | 2025-07-07 | 2025-07-28 | 1888 |  |  | 2025-07-07 | 2025-07-28 | 16d | 39d | 0d |  |  | Participants | Participants | 262.33 | 5.27 | Laura Kennedy | Green | GREEN |
| 1821 | 1.6.4.1.7.6.5.2 | Test Data Generated | 10d | 2025-07-29 | 2025-08-11 | 1820 |  |  | 2025-07-29 | 2025-08-11 | 10d | 39d | 0d |  |  | Non-SIT S&A QT Test Team | Non-SIT S&A QT Test Team | 284.33 | 5.27 | Laura Kennedy | Green | GREEN |
| 1822 | 1.6.4.1.7.6.5.3 | Test Data Loaded into QP Systems | 16d | 2025-08-12 | 2025-09-02 | 1821 |  |  | 2025-08-12 | 2025-09-02 | 16d | 39d | 33d |  |  | Participants | Participants | 298.33 | 5.27 | Laura Kennedy | Green | GREEN |
| 1823 | 1.6.4.1.7.6.5.4 | Test Data Loaded into QTF + ADO | 16d | 2025-08-12 | 2025-09-02 | 1821 |  |  | 2025-08-12 | 2025-09-02 | 16d | 39d | 33d |  |  | Non-SIT S&A QT Test Team | Non-SIT S&A QT Test Team | 298.33 | 5.27 | Laura Kennedy | Green | GREEN |

Notes:
- 1807: Action: 6/8/24: To be split into 2 tasks - jordan awaiting update. Successor?
- 1810: Action: 6/8/24: Will have to reflect the start of the new maintenence window
- 1815: Team confirming when this should take place, expected that the forecast is too late.
- 1816: Team confirming when this should take place, expected that the forecast is too late.

| ID | WBS | Task | Type | Duration | Start | Finish | Predecessors | Complete | Remaining | Baseline start | Baseline finish | Baseline duration | Total slack | Free slack | Constraint | Baseline cost | Responsible | Involved | Task Status | Update Version | MHHS Resource Name | Sched Status | RAG | Milestone ID | Text29 |
| --- | --- | --- | --- | --- | --- | --- | --- | --- | --- | --- | --- | --- | --- | --- | --- | --- | --- | --- | --- | --- | --- | --- | --- | --- | --- |
| 1824 | 1.6.4.1.7.6.6 | **Wave 3 Test Data** |  | 45d | 2025-09-08 | 2025-11-07 |  |  |  | 2025-09-08 | 2025-11-07 | 45d | 29d |  |  |  | N/A | N/A | -596.67 | 5.27 | N/A |  |  |  |  |
| 1825 | 1.6.4.1.7.6.6.1 | Test Data Request + Templates Completed |  | 15d | 2025-09-08 | 2025-09-26 | 1918 |  |  | 2025-09-08 | 2025-09-26 | 15d | 29d | 0d |  |  | Participants | Participants | 325.33 | 5.27 | Laura Kennedy | Green | GREEN |  |  |
| 1826 | 1.6.4.1.7.6.6.2 | Test Data Generated |  | 10d | 2025-09-29 | 2025-10-10 | 1825 |  |  | 2025-09-29 | 2025-10-10 | 10d | 29d | 0d |  |  | Non-SIT S&A QT Test Team | Non-SIT S&A QT Test Team | 346.33 | 5.27 | Laura Kennedy | Green | GREEN |  |  |
| 1827 | 1.6.4.1.7.6.6.3 | Test Data Loaded into QP Systems |  | 20d | 2025-10-13 | 2025-11-07 | 1826 |  |  | 2025-10-13 | 2025-11-07 | 20d | 29d |  |  |  | Participants | Participants | 360.33 | 5.27 | Laura Kennedy | Green | GREEN |  |  |
| 1828 | 1.6.4.1.7.6.6.4 | Test Data Loaded into QTF + ADO |  | 20d | 2025-10-13 | 2025-11-07 | 1826 |  |  | 2025-10-13 | 2025-11-07 | 20d | 29d |  |  |  | Non-SIT S&A QT Test Team | Non-SIT S&A QT Test Team | 360.33 | 5.27 | Laura Kennedy | Green | GREEN |  |  |
| 1829 | 1.6.4.1.7.6.7 | **Wave 4 Test Data** |  | 45d | 2025-10-27 | 2025-12-26 |  |  |  | 2025-10-27 | 2025-12-26 | 45d | 49d |  |  |  | N/A | N/A | -596.67 | 5.27 | N/A |  |  |  |  |
| 1830 | 1.6.4.1.7.6.7.1 | Test Data Request + Templates Completed |  | 15d | 2025-10-27 | 2025-11-14 | 1948 |  |  | 2025-10-27 | 2025-11-14 | 15d | 49d | 0d |  |  | Participants | Participants | 374.33 | 5.27 | Laura Kennedy | Green | GREEN |  |  |
| 1831 | 1.6.4.1.7.6.7.2 | Test Data Generated |  | 10d | 2025-11-17 | 2025-11-28 | 1830 |  |  | 2025-11-17 | 2025-11-28 | 10d | 49d | 0d |  |  | Non-SIT S&A QT Test Team | Non-SIT S&A QT Test Team | 395.33 | 5.27 | Laura Kennedy | Green | GREEN |  |  |
| 1832 | 1.6.4.1.7.6.7.3 | Test Data Loaded into QP Systems |  | 20d | 2025-12-01 | 2025-12-26 | 1831 |  |  | 2025-12-01 | 2025-12-26 | 20d | 49d | 45d |  |  | Participants | Participants | 409.33 | 5.27 | Laura Kennedy | Green | GREEN |  |  |
| 1833 | 1.6.4.1.7.6.7.4 | Test Data Loaded into QTF + ADO |  | 20d | 2025-12-01 | 2025-12-26 | 1831 |  |  | 2025-12-01 | 2025-12-26 | 20d | 49d | 45d |  |  | Non-SIT S&A QT Test Team | Non-SIT S&A QT Test Team | 409.33 | 5.27 | Laura Kennedy | Green | GREEN |  |  |
| 1834 | 1.6.4.1.7.7 | **Governance** |  | 130d | 2024-07-01 A | 2024-12-27 |  | 29% | 92.67d | 2024-07-01 | 2024-12-27 | 130d | 779d |  |  |  | N/A | N/A | -594.67 | 5.27 | N/A |  |  |  |  |
| 1835 | 1.6.4.1.7.7.1 | Onboarding Strategy and Develop Training Requirements & Materials Inc. Day in the Life |  | 65d | 2024-07-01 A | 2024-09-27 | 1761 | 43% | 37d | 2024-07-01 | 2024-09-27 | 65d | 844d | 0d |  |  | Non-SIT S&A QT Test Team | Non-SIT S&A QT Test Team |  | 5.27 | Laura Kennedy | Green | GREEN |  |  |
| 1836 | 1.6.4.1.7.7.2 | Design Approach & Set-Up ADO Tool for Test & Defect Management Tool |  | 45d | 2024-07-01 A | 2024-08-30 | 1835SS | 62% | 17d | 2024-07-01 | 2024-08-30 | 45d | 216d | 0d |  |  | Non-SIT S&A QT Test Team | Non-SIT S&A QT Test Team |  | 5.27 | Laura Kennedy | Green | GREEN |  |  |
| 1837 | 1.6.4.1.7.7.3 | Knowledge Transfer, Training, Demonstrations, Documentation, Governance |  | 85d | 2024-09-02 | 2024-12-27 | 1835SS+45d |  |  | 2024-09-02 | 2024-12-27 | 85d | 176d | 0d |  |  | Non-SIT S&A QT Test Team | Non-SIT S&A QT Test Team | -45.67 | 5.27 | Laura Kennedy | Green | GREEN |  |  |
| 1838 | 1.6.4.1.7.8 | Qualification Testing Wave Readiness Confirmed | milestone | 0d | 2024-12-27 | 2024-12-27 | 1837 |  |  | 2024-12-27 | 2024-12-27 | 0d | 176d | 171d |  |  | Non-SIT S&A QT Test Team | Non-SIT S&A QT Test Team, Code Bodies | 70.71 | 5.25 | Laura Kennedy | Green | GREEN | T3-QU-0117 | QAG |
| 1839 | 1.6.4.1.8 | **Wave Allocation** |  | 129d | 2024-01-02 A | 2024-06-28 A |  | 100% |  | 2024-01-02 | 2024-06-28 | 128d |  |  |  | -0 | N/A | N/A | -133.67 | 5.24 | N/A |  |  |  |  |
| 1840 | 1.6.4.1.8.1 | Draft Pre-Qualification Submission (PQS) document |  | 20d | 2024-01-02 A | 2024-01-29 A |  | 100% |  | 2024-01-02 | 2024-01-29 | 20d |  |  | finish no earlier than 2024-01-26 |  | Code Bodies | Code Bodies |  | 5.24 | Laura Kennedy | Complete | COMPLETE |  |  |
| 1841 | 1.6.4.1.8.2 | Publish PQS document |  | 1d | 2024-01-31 A | 2024-01-31 A |  | 100% |  | 2024-01-31 | 2024-01-31 | 1d |  |  | start no earlier than 2024-01-31 |  | Code Bodies | Code Bodies |  | 5.24 | Laura Kennedy | Complete | COMPLETE |  |  |
| 1842 | 1.6.4.1.8.3 | PQS Submission window |  | 60d | 2024-02-05 A | 2024-04-26 A |  | 100% |  | 2024-02-05 | 2024-04-26 | 60d |  |  | start no earlier than 2024-02-05 |  | Participants | Participants |  | 5.24 | Laura Kennedy | Complete | COMPLETE |  |  |
| 1843 | 1.6.4.1.8.4 | Pre-Qualification Submission and PIT Test Plan Deadline for Submission​ | milestone | 0d | 2024-04-26 A | 2024-04-26 A | 1842 | 100% |  | 2024-04-26 | 2024-04-26 | 0d |  |  |  |  | Participants | Participants |  | 5.25 | Laura Kennedy | Complete | COMPLETE | T3-QU-0118 | QAG |
| 1844 | 1.6.4.1.8.5 | PQS Review by Code Bodies |  | 25d | 2024-04-29 A | 2024-05-31 A | 1842, 1843 | 100% |  | 2024-04-29 | 2024-05-31 | 25d |  |  |  |  | Code Bodies | Code Bodies |  | 5.24 | Laura Kennedy | Complete | COMPLETE |  |  |
| 1845 | 1.6.4.1.8.6 | Draft Wave Allocations |  | 15d | 2024-06-03 A | 2024-06-21 A | 1844 | 100% |  | 2024-06-03 | 2024-06-21 | 15d |  |  |  |  | Code Bodies | Code Bodies |  | 5.24 | Laura Kennedy | Complete | COMPLETE |  |  |
| 1846 | 1.6.4.1.8.7 | Confirmation of participant Qualification Wave allocation | milestone | 0d | 2024-06-28 A | 2024-06-28 A | 1845FS+5d | 100% |  | 2024-06-28 | 2024-06-28 | 0d |  |  |  |  | Code Bodies | Code Bodies |  | 5.28 | Laura Kennedy | Complete | COMPLETE | T3-QU-0012 | QAG |
| 1847 | 1.6.4.2 | **Qualification Wave 1** |  | 275d | 2025-03-24 | 2026-04-10 |  |  |  | 2025-03-24 | 2026-04-10 | 229d | 5d |  |  | -0 | N/A | N/A | -133.67 | 6.1 | N/A |  |  |  |  |
| 1848 | 1.6.4.2.1 | **Qualification Wave 1 QAD Prep** |  | 80d | 2025-03-24 | 2025-07-11 |  |  |  | 2025-03-24 | 2025-07-11 | 80d | 36d |  |  | -0 | N/A | N/A | -152.67 | 6.1 | N/A |  |  |  |  |
| 1849 | 1.6.4.2.1.1 | Initial QAD Submission window opens | milestone | 0d | 2025-03-24 | 2025-03-24 | 1846, 1671FS+121d |  |  | 2025-03-24 | 2025-03-24 | 0d | 36d | 0d |  |  | Participants | Participants | 157.71 | 6.1 | Laura Kennedy | Green | GREEN |  |  |
| 1850 | 1.6.4.2.1.2 | Qualification Wave 1 Participants Submit Initial QAD |  | 50d | 2025-03-24 | 2025-05-30 | 1849FS-1d |  |  | 2025-03-24 | 2025-05-30 | 50d | 36d | 0d |  |  | Participants | Participants | 157.33 | 6.1 | Laura Kennedy | Green | GREEN |  |  |
| 1851 | 1.6.4.2.1.3 | Qualification Wave 1 Participants have submitted their initial QAD | milestone | 0d | 2025-06-02 | 2025-06-02 | 1850FS+1d |  |  | 2025-06-02 | 2025-06-02 | 0d | 36d | 0d |  |  | Participants | Participants | 227.71 | 6.1 | Laura Kennedy | Green | GREEN | T3-QU-0094 | QAG |
| 1852 | 1.6.4.2.1.4 | Code Bodies review of Wave 1 Participants Initial QAD |  | 30d | 2025-06-02 | 2025-07-11 | 1850FS-1d, 1851FS-1d |  |  | 2025-06-02 | 2025-07-11 | 30d | 36d | 0d |  |  | Code Bodies | Code Bodies | 227.33 | 6.1 | Laura Kennedy | Green | GREEN |  |  |
| 1853 | 1.6.4.2.1.5 | Completion of Code Bodies review of Initial QAD | milestone | 0d | 2025-07-11 | 2025-07-11 | 1852 |  |  | 2025-07-11 | 2025-07-11 | 0d | 36d | 0d |  |  | Code Bodies | Code Bodies | 266.71 | 6.1 | Laura Kennedy | Green | GREEN |  |  |

Notes:
- 1849: 25/09/24 - Forecast has moved to 21/03/25, this will be baseliend once CR55 is approved.
- 1850: 25/09/24 - Forecast has moved to 29/05/25, this will be baseliend once CR55 is approved.
- 1851: 25/09/24 - Forecast has moved to 29/05/25, this will be baseliend once CR55 is approved.

| ID | WBS | Task | Type | Duration | Start | Finish | Predecessors | Baseline start | Baseline finish | Baseline duration | Total slack | Free slack | Constraint | Baseline cost | Responsible | Involved | Task Status | Update Version | MHHS Resource Name | Sched Status | RAG | Milestone ID | Text29 |
| --- | --- | --- | --- | --- | --- | --- | --- | --- | --- | --- | --- | --- | --- | --- | --- | --- | --- | --- | --- | --- | --- | --- | --- |
| 1854 | 1.6.4.2.2 | **Qualification Wave 1 Test Prep** |  | 60d | 2025-04-14 | 2025-07-04 |  | 2025-04-14 | 2025-07-04 | 60d | 41d |  |  | -0 | N/A | N/A | -555.67 | 6.1 | N/A |  |  |  |  |
| 1855 | 1.6.4.2.2.1 | Confirmation from Qualification Wave 1 Participants that DIP onboarding has commenced | milestone | 0d | 2025-04-14 | 2025-04-14 |  | 2025-04-14 | 2025-04-14 | 0d | 61d | 0d | start no earlier than 2025-04-14 |  | Participants | Participants | 178.33 | 6.1 | Laura Kennedy | Green | GREEN | T3-QU-0017 | QAG |
| 1856 | 1.6.4.2.2.2 | Qualification Wave 1 Participants DIP Onboarding Window |  | 35d | 2025-04-14 | 2025-05-30 | 1855 | 2025-04-14 | 2025-05-30 | 35d | 61d | 0d |  |  | Participants | Participants | 178.33 | 6.1 | Laura Kennedy | Green | GREEN |  |  |
| 1857 | 1.6.4.2.2.3 | Confirmation from Qualification Wave 1 Participants that DIP onboarding has completed | milestone | 0d | 2025-05-30 | 2025-05-30 | 1856 | 2025-05-30 | 2025-05-30 | 0d | 61d | 25d |  |  | Participants | Participants | 224.71 | 6.1 | Laura Kennedy | Green | GREEN |  |  |
| 1858 | 1.6.4.2.2.4 | Qualification Wave 1 Participants' to provide status of PIT completion and submit QT Test Plan | milestone | 0d | 2025-05-12 | 2025-05-12 |  | 2025-05-12 | 2025-05-12 | 0d | 35d | 0d | start no earlier than 2025-05-12 |  | Participants | Participants | 206.33 | 6.1 | Laura Kennedy | Green | GREEN | T3-QU-0095 | QAG |
| 1859 | 1.6.4.2.2.5 | Review of Participants' PIT Status and QT Test Plan |  | 15d | 2025-05-12 | 2025-05-30 | 1858 | 2025-05-12 | 2025-05-30 | 15d | 61d | 0d |  |  | Code Bodies, Non-SIT S&A QT Test Team | Code Bodies, Non-SIT S&A QT Test Team | 206.33 | 6.1 | Laura Kennedy | Green | GREEN |  |  |
| 1860 | 1.6.4.2.2.6 | Qualification Test Plans for Wave 1 Participants approved | milestone | 0d | 2025-05-30 | 2025-05-30 | 1859 | 2025-05-30 | 2025-05-30 | 0d | 61d | 25d |  |  | Non-SIT S&A QT Test Team | Non-SIT S&A QT Test Team | 224.71 | 6.1 | Laura Kennedy | Green | GREEN | T3-QU-0016 | QAG |
| 1861 | 1.6.4.2.2.7 | Qualification Wave 1 Participants have submitted PIT Test Completion Report and evidence for QT Entry | milestone | 0d | 2025-06-02 | 2025-06-02 |  | 2025-06-02 | 2025-06-02 | 0d | 36d | 0d | start no earlier than 2025-06-02 |  | Participants | Participants | 227.33 | 6.1 | Laura Kennedy | Green | GREEN | T3-QU-0096 | QAG |
| 1862 | 1.6.4.2.2.8 | Review of Participants PIT Test Completion Report |  | 25d | 2025-06-02 | 2025-07-04 | 1861 | 2025-06-02 | 2025-07-04 | 25d | 36d | 0d |  |  | Code Bodies, Non-SIT S&A QT Test Team | Code Bodies, Non-SIT S&A QT Test Team | 227.33 | 6.1 | Laura Kennedy | Green | GREEN |  |  |
| 1863 | 1.6.4.2.2.9 | Onboarding to QTF & ADO |  | 25d | 2025-06-02 | 2025-07-04 | 1862SS, 1780 | 2025-06-02 | 2025-07-04 | 25d | 41d | 36d |  |  | Code Bodies, Non-SIT S&A QT Test Team | Code Bodies, Non-SIT S&A QT Test Team | 227.33 | 6.1 | Laura Kennedy | Green | GREEN |  |  |
| 1864 | 1.6.4.2.3 | **Qualification Wave 1 QT Execution** |  | 130d | 2025-07-07 | 2026-01-02 |  | 2025-07-07 | 2026-01-02 | 100d | 10d |  |  | -0 | N/A | N/A | -152.67 | 6.1 | N/A |  |  |  |  |
| 1865 | 1.6.4.2.3.1 | Review Entry Criteria Evidence for each Wave 1 Participant |  | 5d | 2025-07-07 | 2025-07-11 | 1853FF, 1857, 1860, 1862 | 2025-07-07 | 2025-07-11 | 5d | 36d | 1d |  |  | Non-SIT S&A QT Test Team | Non-SIT S&A QT Test Team | 262.33 | 6.1 | Laura Kennedy | Green | GREEN |  |  |
| 1866 | 1.6.4.2.3.2 | Qualification Wave 1 Participant Test Readiness Confirmed | milestone | 0d | 2025-07-14 | 2025-07-14 | 1852, 1853, 1865FF, 1817, 1818 | 2025-07-14 | 2025-07-14 | 0d | 35d | 30d |  |  | Non-SIT S&A QT Test Team | Non-SIT S&A QT Test Team | 269.71 | 6.1 | Laura Kennedy | Green | GREEN | T3-QU-0027 | QAG |
| 1867 | 1.6.4.2.3.3 | Qualification Wave 1 QT Execution Start | milestone | 0d | 2025-08-25 | 2025-08-25 | 1866, 1838, 1863, 1282FS+6d | 2025-08-25 | 2025-08-25 | 0d | 5d | 0d | start no earlier than 2025-07-14 |  | Participants | Participants | 311.71 | 6.1 | Laura Kennedy | Green | AMBER | T3-QU-0028 | QAG |
| 1868 | 1.6.4.2.3.4 | Qualification Wave 1 QT Execution Window |  | 95d | 2025-08-25 | 2026-01-02 | 1867FS-1d | 2025-08-25 | 2026-01-02 | 95d | 10d | 0d |  |  | Participants | Participants | 311.33 | 6.1 | Laura Kennedy | Green | GREEN |  |  |
| 1869 | 1.6.4.2.3.5 | Qualification Wave 1 QT Projected Execution End | milestone | 0d | 2026-01-02 | 2026-01-02 | 1868 | 2026-01-02 | 2026-01-02 | 0d | 10d | 5d |  |  | Participants | Participants | 441.71 | 6.1 | Laura Kennedy | Green | GREEN | T3-QU-0054 | QAG |
| 1870 | 1.6.4.2.4 | **Qualification Wave 1 Exit** |  | 165d | 2025-08-25 | 2026-04-10 |  | 2025-08-25 | 2026-04-10 | 149d? | 5d |  |  | -0 | N/A | N/A | -152.67 | 6.1 | N/A |  |  |  |  |
| 1871 | 1.6.4.2.4.1 | Final QAD Submission window opens | milestone | 0d | 2025-08-25 | 2025-08-25 | 1867 | 2025-08-25 | 2025-08-25 | 0d | 5d | 0d |  |  | Participants | Participants | 311.71 | 6.1 | Laura Kennedy | Green | GREEN |  |  |
| 1872 | 1.6.4.2.4.2 | Qualification Wave 1 Participants submit their Final QAD |  | 100d | 2025-08-25 | 2026-01-09 | 1871FS-1d | 2025-08-25 | 2026-01-09 | 100d | 5d | 0d |  |  | Participants | Participants | 311.33 | 6.1 | Laura Kennedy | Green | GREEN |  |  |
| 1873 | 1.6.4.2.4.3 | Qualification Wave 1 Participants have submitted their final QAD | milestone | 0d | 2026-01-09 | 2026-01-09 | 1872, 1869 | 2026-01-09 | 2026-01-09 | 0d | 5d | 0d |  |  | Participants | Participants | 448.71 | 6.1 | Laura Kennedy | Green | GREEN | T3-QU-0097 | QAG |
| 1874 | 1.6.4.2.4.4 | Completion of Code Bodies review of Final QAD |  | 35d | 2026-01-12 | 2026-02-27 | 1872, 1873 | 2026-01-12 | 2026-02-27 | 20d | 5d | 0d |  |  | Code Bodies | Code Bodies | 451.33 | 6.1 | Laura Kennedy | Green | GREEN |  |  |
| 1875 | 1.6.4.2.4.5 | QAD Sign Off deadline |  | 1d | 2026-03-13 | 2026-03-13 | 1874FS+9d | 2026-03-13 | 2026-03-13 | 1d | 5d | 0d |  |  | Participants | Participants | 511.33 | 6.1 | Laura Kennedy | Green | GREEN |  |  |
| 1876 | 1.6.4.2.4.6 | Qualification Wave 1 Participants Qualification approved by BSC PAB and REC Manager | milestone | 0d | 2026-04-10 | 2026-04-10 | 1875FS+20d | 2026-04-10 | 2026-04-10 | 0d | 5d | 0d |  |  | Code Bodies | Code Bodies | 539.71 | 6.1 | Laura Kennedy | Green | GREEN | T2-QU-0150 | QAG |
| 1877 | 1.6.4.3 | **Qualification Wave 2** |  | 253d | 2025-06-09 | 2026-05-27 |  | 2025-06-09 | 2026-05-27 | 249d | 6d |  |  | -0 | N/A | N/A | -133.67 | 6.1 | N/A |  |  |  |  |
| 1878 | 1.6.4.3.1 | **Qualification Wave 2 QAD Prep** |  | 95d | 2025-06-09 | 2025-10-17 |  | 2025-06-09 | 2025-10-17 | 96d | 6d |  |  | -0 | N/A | N/A | -154.67 | 6.1 | N/A |  |  |  |  |
| 1879 | 1.6.4.3.1.1 | Initial QAD Submission window opens | milestone | 0d | 2025-06-09 | 2025-06-09 | 1672FS+151d | 2025-06-09 | 2025-06-09 | 0d | 6d | 0d |  |  | Participants | Participants | 234.71 | 6.1 | Laura Kennedy | Green | GREEN |  |  |
| 1880 | 1.6.4.3.1.2 | Qualification Wave 2 Participants Submit Initial QAD |  | 70d | 2025-06-09 | 2025-09-12 | 1879FS-1d | 2025-06-09 | 2025-09-12 | 70d | 6d | 0d |  |  | Participants | Participants | 234.33 | 6.1 | Laura Kennedy | Green | GREEN |  |  |
| 1881 | 1.6.4.3.1.3 | Qualification Wave 2 Participants have submitted their initial QAD | milestone | 0d | 2025-09-12 | 2025-09-12 | 1880 | 2025-09-12 | 2025-09-12 | 0d | 6d | 0d |  |  | Participants | Participants | 329.71 | 6.1 | Laura Kennedy | Green | GREEN | T3-QU-0098 | QAG |
| 1882 | 1.6.4.3.1.4 | Code Bodies review of Wave 2 Participants' Initial QAD |  | 25d | 2025-09-15 | 2025-10-17 | 1881 | 2025-09-15 | 2025-10-17 | 26d | 6d | 0d |  |  | Code Bodies | Code Bodies | 332.33 | 6.1 | Laura Kennedy | Green | GREEN |  |  |
| 1883 | 1.6.4.3.1.5 | Completion of Code Bodies review of Initial QAD | milestone | 0d | 2025-10-17 | 2025-10-17 | 1882 | 2025-10-17 | 2025-10-17 | 0d | 6d | 0d |  |  | Code Bodies | Code Bodies | 364.71 | 6.1 | Laura Kennedy | Green | GREEN |  |  |

Notes:
- 1855: 25/09/24 - Forecast has moved to 14/04/25, this will be baseliend once CR55 is approved.
- 1856: 25/09/24 - Forecast has moved to 30/05/25, this will be baseliend once CR55 is approved.
- 1857: 25/09/24 - Forecast has moved to 30/05/25, this will be baseliend once CR55 is approved.
- 1858: 25/09/24 - Forecast has moved to 12/05/25, this will be baseliend once CR55 is approved.
- 1859: 25/09/24 - Forecast has moved to 30/05/25, this will be baseliend once CR55 is approved.
- 1860: 25/09/24 - Forecast has moved to 30/05/25, this will be baseliend once CR55 is approved.
- 1861: 25/09/24 - Forecast has moved to 02/06/25, this will be baseliend once CR55 is approved.
- 1867: 16/09/24 - Date updated to 14/07/25, in line with recalibration planning.
- 1879: 25/09/24 - Forecast has moved to 25/04/25, this will be baseliend once CR55 is approved.

| ID | WBS | Task | Type | Duration | Start | Finish | Predecessors | Baseline start | Baseline finish | Baseline duration | Total slack | Free slack | Constraint | Baseline cost | Responsible | Involved | Task Status | Update Version | MHHS Resource Name | Sched Status | RAG | Milestone ID | Text29 |
| --- | --- | --- | --- | --- | --- | --- | --- | --- | --- | --- | --- | --- | --- | --- | --- | --- | --- | --- | --- | --- | --- | --- | --- |
| 1884 | 1.6.4.3.2 | **Qualification Wave 2 Test Prep** |  | 60d | 2025-06-09 | 2025-08-29 |  | 2025-06-09 | 2025-08-29 | 60d | 42d |  |  | -0 | N/A | N/A | -555.67 | 6.1 | N/A |  |  |  |  |
| 1885 | 1.6.4.3.2.1 | Confirmation from Qualification Wave 2 Participants that DIP Onboarding has commenced | milestone | 0d | 2025-06-09 | 2025-06-09 |  | 2025-06-09 | 2025-06-09 | 0d | 61d | 0d | start no earlier than 2025-06-09 |  | Participants | Participants | 234.33 | 6.1 | Laura Kennedy | Green | GREEN | T3-QU-0021 | QAG |
| 1886 | 1.6.4.3.2.2 | Qualification Wave 2 Participants DIP Onboarding Window |  | 35d | 2025-06-09 | 2025-07-25 | 1885 | 2025-06-09 | 2025-07-25 | 40d | 61d | 0d |  |  | Participants | Participants | 234.33 | 6.1 | Laura Kennedy | Green | GREEN |  |  |
| 1887 | 1.6.4.3.2.3 | Confirmation from Qualificiation Wave 2 Participants that DIP onboarding has completed | milestone | 0d | 2025-07-25 | 2025-07-25 | 1886 | 2025-07-25 | 2025-07-25 | 0d | 61d | 55d |  |  | Participants | Participants | 280.71 | 6.1 | Laura Kennedy | Green | GREEN |  |  |
| 1888 | 1.6.4.3.2.4 | Qualification Wave 2 Participants' to provide status of PIT completion and submit QT Test Plan | milestone | 0d | 2025-07-07 | 2025-07-07 |  | 2025-07-07 | 2025-07-07 | 0d | 39d | 0d | start no earlier than 2025-07-07 |  | Participants | Participants | 262.33 | 6.1 | Laura Kennedy | Green | GREEN | T3-QU-0099 | QAG |
| 1889 | 1.6.4.3.2.5 | Review of Participants' PIT Status and QT Test Plan |  | 15d | 2025-07-07 | 2025-07-25 | 1888 | 2025-07-07 | 2025-07-25 | 15d | 61d | 0d | start no earlier than 2025-07-07 |  | Code Bodies, Non-SIT S&A QT Test Team | Code Bodies, Non-SIT S&A QT Test Team | 262.33 | 6.1 | Laura Kennedy | Green | GREEN |  |  |
| 1890 | 1.6.4.3.2.6 | Qualification Test Plans for Wave 2 Participants approved | milestone | 0d | 2025-07-25 | 2025-07-25 | 1889 | 2025-07-25 | 2025-07-25 | 0d | 61d | 55d | start no earlier than 2025-07-25 |  | Non-SIT S&A QT Test Team | Non-SIT S&A QT Test Team | 280.71 | 6.1 | Laura Kennedy | Green | GREEN | T3-QU-0020 | QAG |
| 1891 | 1.6.4.3.2.7 | Qualification Wave 2 Participants have submitted PIT Test Completion Report and evidence for QT entry | milestone | 0d | 2025-07-28 | 2025-07-28 |  | 2025-07-28 | 2025-07-28 | 0d | 36d | 0d | start no earlier than 2025-07-28 |  | Participants | Participants | 283.33 | 6.1 | Laura Kennedy | Green | GREEN | T3-QU-0100 | QAG |
| 1892 | 1.6.4.3.2.8 | Review of Participants' PIT Test Completion Report |  | 25d | 2025-07-28 | 2025-08-29 | 1891 | 2025-07-28 | 2025-08-29 | 25d | 36d | 0d |  |  | Code Bodies, Non-SIT S&A QT Test Team | Code Bodies, Non-SIT S&A QT Test Team | 283.33 | 6.1 | Laura Kennedy | Green | GREEN |  |  |
| 1893 | 1.6.4.3.2.9 | Onboarding to QTF & ADO |  | 25d | 2025-07-28 | 2025-08-29 | 1892SS | 2025-07-28 | 2025-08-29 | 25d | 42d | 36d |  |  | Code Bodies, Non-SIT S&A QT Test Team | Code Bodies, Non-SIT S&A QT Test Team | 283.33 | 6.1 | Laura Kennedy | Green | GREEN |  |  |
| 1894 | 1.6.4.3.3 | **Qualification Wave 2 QT Execution** |  | 100d | 2025-10-13 | 2026-02-27 |  | 2025-10-13 | 2026-02-27 | 99d | 6d |  |  | -0 | N/A | N/A | -154.67 | 6.1 | N/A |  |  |  |  |
| 1895 | 1.6.4.3.3.1 | Review Entry Criteria Evidence for each Wave 2 Participant |  | 5d | 2025-10-13 | 2025-10-17 | 1883FF, 1887, 1890, 1892 | 2025-10-13 | 2025-10-17 | 5d | 6d | 0d |  |  | Non-SIT S&A QT Test Team | Non-SIT S&A QT Test Team | 360.33 | 6.1 | Laura Kennedy | Green | GREEN |  |  |
| 1896 | 1.6.4.3.3.2 | Qualification Wave 2 Participant Test Readiness Confirmed | milestone | 0d | 2025-10-17 | 2025-10-17 | 1895, 1883, 1822, 1823 | 2025-10-17 | 2025-10-17 | 0d | 6d | 0d |  |  | Non-SIT S&A QT Test Team | Non-SIT S&A QT Test Team | 364.71 | 6.1 | Laura Kennedy | Green | GREEN | T3-QU-0033 | QAG |
| 1897 | 1.6.4.3.3.3 | Qualification Wave 2 Execution Start | milestone | 0d | 2025-10-20 | 2025-10-20 | 1896FS+1d, 1893 | 2025-10-20 | 2025-10-20 | 0d | 6d | 0d |  |  | Participants | Participants | 367.71 | 6.1 | Laura Kennedy | Green | AMBER | T3-QU-0034 | QAG |
| 1898 | 1.6.4.3.3.4 | Qualification Wave 2 QT Execution Window |  | 95d | 2025-10-20 | 2026-02-27 | 1897SS-1d | 2025-10-20 | 2026-02-27 | 94d | 11d | 0d |  |  | Participants | Participants | 367.33 | 6.1 | Laura Kennedy | Green | GREEN |  |  |
| 1899 | 1.6.4.3.3.5 | Qualfication Wave 2 QT Execution End | milestone | 0d | 2026-02-27 | 2026-02-27 | 1898 | 2026-02-27 | 2026-02-27 | 0d | 11d | 5d |  |  | Participants | Participants | 497.71 | 6.1 | Laura Kennedy | Green | GREEN | T3-QU-0055 | QAG |
| 1900 | 1.6.4.3.4 | **Qualification Wave 2 Exit** |  | 158d | 2025-10-20 | 2026-05-27 |  | 2025-10-20 | 2026-05-27 | 153d | 6d |  |  | -0 | N/A | N/A | -154.67 | 6.1 | N/A |  |  |  |  |
| 1901 | 1.6.4.3.4.1 | Final QAD Submission window opens | milestone | 0d | 2025-10-20 | 2025-10-20 | 1897 | 2025-10-20 | 2025-10-20 | 0d | 6d | 0d |  |  | Participants | Participants | 367.71 | 6.1 | Laura Kennedy | Green | GREEN |  |  |
| 1902 | 1.6.4.3.4.2 | Qualification Wave 2 Participants submit their Final QAD |  | 100d | 2025-10-20 | 2026-03-06 | 1901FS-1d | 2025-10-20 | 2026-03-06 | 99d | 6d | 0d |  |  | Participants | Participants | 367.33 | 6.1 | Laura Kennedy | Green | GREEN |  |  |
| 1903 | 1.6.4.3.4.3 | Qualification Wave 2 Participants have submitted their final QAD | milestone | 0d | 2026-03-06 | 2026-03-06 | 1902, 1899 | 2026-03-06 | 2026-03-06 | 0d | 6d | 0d |  |  | Participants | Participants | 504.71 | 6.1 | Laura Kennedy | Green | GREEN | T3-QU-0101 | QAG |
| 1904 | 1.6.4.3.4.4 | Completion of Code Bodies review of Final QAD |  | 26d | 2026-03-09 | 2026-04-13 | 1903 | 2026-03-09 | 2026-04-13 | 27d | 6d | 0d |  |  | Code Bodies | Code Bodies | 507.33 | 6.1 | Laura Kennedy | Green | GREEN |  |  |
| 1905 | 1.6.4.3.4.5 | QAD Sign Off deadline |  | 1d | 2026-04-20 | 2026-04-20 | 1904FS+4d | 2026-04-20 | 2026-04-20 | 1d | 6d | 0d |  |  | Participants | Participants | 549.33 | 6.1 | Laura Kennedy | Green | GREEN |  |  |
| 1906 | 1.6.4.3.4.6 | Qualification Wave 2 Participants Qualification approved by BSC PAB and REC Manager | milestone | 0d | 2026-05-27 | 2026-05-27 | 1905FS+27d | 2026-05-27 | 2026-05-27 | 0d | 6d | 0d |  |  | Code Bodies | Code Bodies | 586.71 | 6.1 | Laura Kennedy | Green | GREEN | T2-QU-0200 | QAG |
| 1907 | 1.6.4.4 | **Qualification Wave 3** |  | 254d | 2025-08-04 | 2026-07-23 |  | 2025-08-04 | 2026-07-23 | 239d | 5d |  |  | -0 | N/A | N/A | -133.67 | 6.1 | N/A |  |  |  |  |
| 1908 | 1.6.4.4.1 | **Qualification Wave 3 QAD Prep** |  | 95d | 2025-08-11 | 2025-12-19 |  | 2025-08-11 | 2025-12-19 | 95d | 0d |  |  | -0 | N/A | N/A | -154.67 | 6.1 | N/A |  |  |  |  |
| 1909 | 1.6.4.4.1.1 | Initial QAD Submission window opens | milestone | 0d | 2025-08-11 | 2025-08-11 | 1673FS+151d | 2025-08-11 | 2025-08-11 | 0d | 0d |  |  |  | Participants | Participants | 297.71 | 6.1 | Laura Kennedy | Green | GREEN |  |  |
| 1910 | 1.6.4.4.1.2 | Qualification Wave 3 Participants Submit Initial QAD |  | 65d | 2025-08-11 | 2025-11-07 | 1909FS-1d | 2025-08-11 | 2025-11-07 | 65d | 0d |  |  |  | Participants | Participants | 297.33 | 6.1 | Laura Kennedy | Green | GREEN |  |  |
| 1911 | 1.6.4.4.1.3 | Qualification Wave 3 Participants have submitted their initial QAD | milestone | 0d | 2025-11-07 | 2025-11-07 | 1910 | 2025-11-07 | 2025-11-07 | 0d | 0d |  |  |  | Participants | Participants | 385.71 | 6.1 | Laura Kennedy | Green | GREEN | T3-QU-0102 | QAG |
| 1912 | 1.6.4.4.1.4 | Code Bodies review of Wave 3 Participants' Initial QAD |  | 30d | 2025-11-10 | 2025-12-19 | 1911 | 2025-11-10 | 2025-12-19 | 30d | 0d |  |  |  | Code Bodies | Code Bodies | 388.33 | 6.1 | Laura Kennedy | Green | GREEN |  |  |
| 1913 | 1.6.4.4.1.5 | Completion of Code Bodies review of Initial QAD | milestone | 0d | 2025-12-19 | 2025-12-19 | 1912 | 2025-12-19 | 2025-12-19 | 0d | 0d |  |  |  | Code Bodies | Code Bodies | 427.71 | 6.1 | Laura Kennedy | Green | GREEN |  |  |

Notes:
- 1885: 25/09/24 - Forecast has moved to 02/06/25, this will be baseliend once CR55 is approved.
- 1897: 6/8/24: Date at risk from scenario planning activity
- 1906: 14/5: Baseline and name updated after cr48 approval at psg on 1/5

| ID | WBS | Task | Type | Duration | Start | Finish | Predecessors | Baseline start | Baseline finish | Baseline duration | Total slack | Free slack | Constraint | Baseline cost | Responsible | Involved | Task Status | Update Version | MHHS Resource Name | Sched Status | RAG | Milestone ID | Text29 |
| --- | --- | --- | --- | --- | --- | --- | --- | --- | --- | --- | --- | --- | --- | --- | --- | --- | --- | --- | --- | --- | --- | --- | --- |
| 1914 | 1.6.4.4.2 | **Qualification Wave 3 Test Prep** |  | 65d | 2025-08-04 | 2025-10-31 |  | 2025-08-04 | 2025-10-31 | 65d | 54d |  |  | -0 | N/A | N/A | -555.67 | 6.1 | N/A |  |  |  |  |
| 1915 | 1.6.4.4.2.1 | Confirmation from Qualification Wave 3 Participants that DIP Onboarding has commenced | milestone | 0d | 2025-08-04 | 2025-08-04 |  | 2025-08-04 | 2025-08-04 | 0d | 60d | 0d | start no earlier than 2025-08-04 |  | Participants | Participants | 290.33 | 6.1 | Laura Kennedy | Green | GREEN | T3-QU-0025 | QAG |
| 1916 | 1.6.4.4.2.2 | Qualification Wave 3 Participants DIP Onboarding window |  | 35d | 2025-08-04 | 2025-09-19 | 1915 | 2025-08-04 | 2025-09-19 | 40d | 60d | 0d | start no earlier than 2025-08-04 |  | Participants | Participants | 290.33 | 6.1 | Laura Kennedy | Green | GREEN |  |  |
| 1917 | 1.6.4.4.2.3 | Confirmation from Qualification Wave 3 Participants that DIP onboarding has completed | milestone | 0d | 2025-09-22 | 2025-09-22 | 1916 | 2025-09-22 | 2025-09-22 | 0d | 60d |  | start no earlier than 2025-09-22 |  | Participants | Participants | 339.33 | 6.1 | Laura Kennedy | Green | GREEN |  |  |
| 1918 | 1.6.4.4.2.4 | Qualification Wave 3 Participants' to provide status of PIT completion and submit QT Test Plan | milestone | 0d | 2025-09-08 | 2025-09-08 |  | 2025-09-08 | 2025-09-08 | 0d | 29d | 0d | start no earlier than 2025-09-08 |  | Participants | Participants | 325.33 | 6.1 | Laura Kennedy | Green | GREEN | T3-QU-0103 | QAG |
| 1919 | 1.6.4.4.2.5 | Review of Participants' PIT Status and QT Test Plan |  | 15d | 2025-09-08 | 2025-09-26 | 1918 | 2025-09-08 | 2025-09-26 | 15d | 584d | 0d | start no earlier than 2025-09-08 |  | Code Bodies, Non-SIT S&A QT Test Team | Code Bodies, Non-SIT S&A QT Test Team | 325.33 | 6.1 | Laura Kennedy | Green | GREEN |  |  |
| 1920 | 1.6.4.4.2.6 | Qualification Test Plans for Wave 3 Participants approved | milestone | 0d | 2025-09-26 | 2025-09-26 | 1919 | 2025-09-26 | 2025-09-26 | 0d | 584d |  | start no earlier than 2025-09-26 |  | Non-SIT S&A QT Test Team | Non-SIT S&A QT Test Team | 343.71 | 6.1 | Laura Kennedy | Green | GREEN | T3-QU-0024 | QAG |
| 1921 | 1.6.4.4.2.7 | Qualification Wave 3 Participants have submitted PIT Test Completion Report and evidence for QT Entry | milestone | 0d | 2025-09-29 | 2025-09-29 |  | 2025-09-29 | 2025-09-29 | 0d | 30d | 0d | start no earlier than 2025-09-29 |  | Participants | Participants | 346.33 | 6.1 | Laura Kennedy | Green | GREEN | T3-QU-0104 | QAG |
| 1922 | 1.6.4.4.2.8 | Review of Participants' PIT Test Completion Report |  | 25d | 2025-09-29 | 2025-10-31 | 1921 | 2025-09-29 | 2025-10-31 | 30d | 30d | 0d | start no earlier than 2025-09-29 |  | Code Bodies, Non-SIT S&A QT Test Team | Code Bodies, Non-SIT S&A QT Test Team | 346.33 | 6.1 | Laura Kennedy | Green | GREEN |  |  |
| 1923 | 1.6.4.4.2.9 | Onboarding to QTF & ADO |  | 25d | 2025-09-29 | 2025-10-31 | 1922SS | 2025-09-29 | 2025-10-31 | 30d | 30d |  | finish no earlier than 2025-10-31 |  |  |  | 346.33 | 6.1 | Laura Kennedy | Green | GREEN |  |  |
| 1924 | 1.6.4.4.3 | **Qualification Wave 3 QT Execution** |  | 102d | 2025-11-03 | 2026-03-24 |  | 2025-11-03 | 2026-03-24 | 100d |  |  |  | -0 | N/A | N/A | -154.67 | 6.1 | N/A |  |  |  |  |
| 1925 | 1.6.4.4.3.1 | Review Entry Criteria Evidence for each Wave 3 Participant |  | 5d | 2025-12-15 | 2025-12-19 | 1917, 1913FF, 1923 | 2025-12-15 | 2025-12-19 | 5d | 0d |  | start no earlier than 2025-11-03 |  | Non-SIT S&A QT Test Team | Non-SIT S&A QT Test Team | 423.33 | 6.1 | Laura Kennedy | Green | GREEN |  |  |
| 1926 | 1.6.4.4.3.2 | Qualification Wave 3 Participant Test Readiness confirmed | milestone | 0d | 2025-12-19 | 2025-12-19 | 1917, 1925FS-1d, 1827, 1828 | 2025-12-19 | 2025-12-19 | 0d | 0d |  |  |  | Non-SIT S&A QT Test Team | Non-SIT S&A QT Test Team | 427.33 | 6.1 | Laura Kennedy | Green | GREEN | T3-QU-0038 | QAG |
| 1927 | 1.6.4.4.3.3 | Qualification Wave 3 Execution Start | milestone | 0d | 2026-01-05 | 2026-01-05 | 1926FS+12d, 1923FS+1d | 2026-01-05 | 2026-01-05 | 0d | 0d |  | start no earlier than 2025-11-03 |  | Participants | Participants | 444.71 | 6.1 | Laura Kennedy | Green | AMBER | T3-QU-0039 | QAG |
| 1928 | 1.6.4.4.3.4 | Qualification Wave 3 QT Execution Window |  | 95d | 2026-01-05 | 2026-05-15 | 1925, 1927FS-1d | 2026-01-05 | 2026-05-15 | 95d | 5d | 0d |  |  | Participants | Participants | 444.33 | 6.1 | Laura Kennedy | Green | GREEN |  |  |
| 1929 | 1.6.4.4.3.5 | Qualification Wave 3 Projected Execution End | milestone | 0d | 2026-05-15 | 2026-05-15 | 1928 | 2026-05-15 | 2026-05-15 | 0d | 5d |  |  |  | Participants | Participants | 574.71 | 6.1 | Laura Kennedy | Green | GREEN | T3-QU-0056 | QAG |
| 1930 | 1.6.4.4.4 | **Qualification Wave 3 Exit** |  | 144d | 2026-01-05 | 2026-07-23 |  | 2026-01-05 | 2026-07-23 | 144d | 0d |  |  | -0 | N/A | N/A | -154.67 | 6.1 | N/A |  |  |  |  |
| 1931 | 1.6.4.4.4.1 | Final QAD Submission window opens | milestone | 0d | 2026-01-05 | 2026-01-05 | 1927 | 2026-01-05 | 2026-01-05 | 0d | 0d |  |  |  | Participants | Participants | 444.71 | 6.1 | Laura Kennedy | Green | GREEN |  |  |
| 1932 | 1.6.4.4.4.2 | Qualification Wave 3 Participants submit their Final QAD |  | 100d | 2026-01-05 | 2026-05-22 | 1931FS-1d | 2026-01-05 | 2026-05-22 | 100d | 0d |  |  |  | Participants | Participants | 444.33 | 6.1 | Laura Kennedy | Green | GREEN |  |  |
| 1933 | 1.6.4.4.4.3 | Qualification Wave 3 Participants have submitted their Final QAD | milestone | 0d | 2026-05-22 | 2026-05-22 | 1932, 1929 | 2026-05-22 | 2026-05-22 | 0d | 0d |  |  |  | Participants | Participants | 581.71 | 6.1 | Laura Kennedy | Green | GREEN | T3-QU-0105 | QAG |
| 1934 | 1.6.4.4.4.4 | Completion of Code Bodies review of Final QAD |  | 20d | 2026-05-25 | 2026-06-19 | 1933 | 2026-05-25 | 2026-06-19 | 20d | 0d |  |  |  | Code Bodies | Code Bodies | 584.33 | 6.1 | Laura Kennedy | Green | GREEN |  |  |
| 1935 | 1.6.4.4.4.5 | QAD Sign Off deadline |  | 1d | 2026-06-26 | 2026-06-26 | 1934FS+4d | 2026-06-26 | 2026-06-26 | 1d | 0d |  |  |  | Participants | Participants | 616.33 | 6.1 | Laura Kennedy | Green | GREEN |  |  |
| 1936 | 1.6.4.4.4.6 | Qualification Wave 3 Participants Qualification approved by BSC PAB and REC Manager | milestone | 0d | 2026-07-23 | 2026-07-23 | 1935FS+19d | 2026-07-23 | 2026-07-23 | 0d | 0d |  |  |  | Code Bodies | Code Bodies | 643.71 | 6.1 | Laura Kennedy | Green | GREEN | T2-QU-0250 | QAG |
| 1937 | 1.6.4.5 | **Qualification Wave 4** |  | 354d | 2025-09-22 | 2027-01-28 |  | 2025-09-22 | 2027-01-28 | 249d | 24d |  |  | -0 | N/A | N/A | -133.67 | 6.1 | N/A |  |  |  |  |
| 1938 | 1.6.4.5.1 | **Qualification Wave 4 QAD Prep** |  | 95d | 2025-10-20 | 2026-02-27 |  | 2025-10-20 | 2026-02-27 | 99d | 4d |  |  | -0 | N/A | N/A | -155.67 | 6.1 | N/A |  |  |  |  |
| 1939 | 1.6.4.5.1.1 | Initial QAD Submission window opens | milestone | 0d | 2025-10-20 | 2025-10-20 | 1674FS+161d | 2025-10-20 | 2025-10-20 | 0d | 4d | 0d |  |  | Participants | Participants | 367.71 | 6.1 | Laura Kennedy | Green | GREEN |  |  |
| 1940 | 1.6.4.5.1.2 | Qualification Wave 4 Participants Submit Initial QAD |  | 65d | 2025-10-20 | 2026-01-16 | 1939FS-1d | 2025-10-20 | 2026-01-16 | 70d | 4d | 0d |  |  | Participants | Participants | 367.33 | 6.1 | Laura Kennedy | Green | GREEN |  |  |
| 1941 | 1.6.4.5.1.3 | Qualification Wave 4 Participants have submitted their Initial QAD | milestone | 0d | 2026-01-16 | 2026-01-16 | 1940 | 2026-01-16 | 2026-01-16 | 0d | 4d | 0d |  |  | Participants | Participants | 455.71 | 6.1 | Laura Kennedy | Green | GREEN | T3-QU-0106 | QAG |
| 1942 | 1.6.4.5.1.4 | Code Bodies review of Wave 4 Participants' Initial QAD |  | 30d | 2026-01-19 | 2026-02-27 | 1941 | 2026-01-19 | 2026-02-27 | 29d | 4d | 0d |  |  | Code Bodies | Code Bodies | 458.33 | 6.1 | Laura Kennedy | Green | GREEN |  |  |
| 1943 | 1.6.4.5.1.5 | Completion of Code Bodies review of Initial QAD | milestone | 0d | 2026-02-27 | 2026-02-27 | 1942 | 2026-02-27 | 2026-02-27 | 0d | 4d | 0d |  |  | Code Bodies | Code Bodies | 497.71 | 6.1 | Laura Kennedy | Green | GREEN |  |  |

Notes:
- 1927: 6/8/24: Date at risk from scenario planning activity
- 1936: 14/5: Baseline and name updated after cr48 approval at psg on 1/5

| ID | WBS | Task | Type | Duration | Start | Finish | Predecessors | Baseline start | Baseline finish | Baseline duration | Baseline 1 start | Baseline 1 finish | Total slack | Free slack | Constraint | Baseline cost | Responsible | Involved | Task Status | Update Version | MHHS Resource Name | Sched Status | RAG | Milestone ID | Text29 | MHHS Programme Phase | Tier |
| --- | --- | --- | --- | --- | --- | --- | --- | --- | --- | --- | --- | --- | --- | --- | --- | --- | --- | --- | --- | --- | --- | --- | --- | --- | --- | --- | --- |
| 1944 | 1.6.4.5.2 | **Qualification Wave 4 Test Prep** |  | 65d | 2025-09-22 | 2025-12-19 |  | 2025-09-22 | 2025-12-19 | 67d |  |  | 60d |  |  | -0 | N/A | N/A | -555.67 | 6.1 | N/A |  |  |  |  |  |  |
| 1945 | 1.6.4.5.2.1 | Confirmation from Qualification 4 Participants that DIP Onboarding has commenced | milestone | 0d | 2025-09-22 | 2025-09-22 |  | 2025-09-22 | 2025-09-22 | 0d |  |  | 79d | 0d | start no earlier than 2025-09-22 |  | Participants | Participants | 339.33 | 6.1 | Laura Kennedy | Green | GREEN | T3-QU-0031 | QAG |  |  |
| 1946 | 1.6.4.5.2.2 | Qualification Wave 4 Participants DIP Onboarding Window |  | 35d | 2025-09-22 | 2025-11-07 | 1945 | 2025-09-22 | 2025-11-07 | 42d |  |  | 79d | 0d |  |  | Participants | Participants | 339.33 | 6.1 | Laura Kennedy | Green | GREEN |  |  |  |  |
| 1947 | 1.6.4.5.2.3 | Confirmation from Qualification Wave 4 Participants that DIP onboarding has completed | milestone | 0d | 2025-11-07 | 2025-11-07 | 1946 | 2025-11-07 | 2025-11-07 | 0d |  |  | 79d | 75d |  |  | Participants | Participants | 385.71 | 6.1 | Laura Kennedy | Green | GREEN |  |  |  |  |
| 1948 | 1.6.4.5.2.4 | Qualification Wave 4 Participants' to provide status of PIT completion and submit QT Test Plan | milestone | 0d | 2025-10-27 | 2025-10-27 |  | 2025-10-27 | 2025-10-27 | 0d |  |  | 49d | 0d | start no earlier than 2025-10-27 |  | Participants | Participants | 374.33 | 6.1 | Laura Kennedy | Green | GREEN | T3-QU-0107 | QAG |  |  |
| 1949 | 1.6.4.5.2.5 | Review of Participants' PIT Status and QT Test Plan |  | 15d | 2025-10-27 | 2025-11-14 | 1948 | 2025-10-27 | 2025-11-14 | 16d |  |  | 60d | 0d |  |  | Code Bodies, Non-SIT S&A QT Test Team | Code Bodies, Non-SIT S&A QT Test Team | 374.33 | 6.1 | Laura Kennedy | Green | GREEN |  |  |  |  |
| 1950 | 1.6.4.5.2.6 | Qualification Test Plans for Qualification Wave 4 Participants approved | milestone | 0d | 2025-11-14 | 2025-11-14 | 1949 | 2025-11-14 | 2025-11-14 | 0d |  |  | 60d | 0d |  |  | Non-SIT S&A QT Test Team | Non-SIT S&A QT Test Team | 392.71 | 6.1 | Laura Kennedy | Green | GREEN | T3-QU-0030 | QAG |  |  |
| 1951 | 1.6.4.5.2.7 | Qualification Wave 4 Participants have submitted PIT Test Completion Report and evidence for QT entry | milestone | 0d | 2025-11-14 | 2025-11-14 | 1950 | 2025-11-14 | 2025-11-14 | 0d |  |  | 60d | 0d |  |  | Participants | Participants | 392.71 | 6.1 | Laura Kennedy | Green | GREEN | T3-QU-0108 | QAG |  |  |
| 1952 | 1.6.4.5.2.8 | Review of Participants' PIT Test Completion Report |  | 25d | 2025-11-17 | 2025-12-19 | 1951 | 2025-11-17 | 2025-12-19 | 30d |  |  | 60d | 5d |  |  | Code Bodies, Non-SIT S&A QT Test Team | Code Bodies, Non-SIT S&A QT Test Team | 395.33 | 6.1 | Laura Kennedy | Green | GREEN |  |  |  |  |
| 1953 | 1.6.4.5.2.9 | Onboarding to QTF & ADO |  | 20d | 2025-11-24 | 2025-12-19 | 1952SS | 2025-11-24 | 2025-12-19 | 30d |  |  | 55d | 51d | start no earlier than 2025-11-24 |  | Code Bodies, Non-SIT S&A QT Test Team | Code Bodies, Non-SIT S&A QT Test Team | 402.33 | 6.1 | Laura Kennedy | Green | GREEN |  |  |  |  |
| 1954 | 1.6.4.5.3 | **Qualification Wave 4 QT Execution** |  | 100d | 2026-02-23 | 2026-07-10 |  | 2026-02-23 | 2026-07-10 | 101d |  |  | 4d |  |  | -0 | N/A | N/A | -155.67 | 6.1 | N/A |  |  |  |  |  |  |
| 1955 | 1.6.4.5.3.1 | Review Entry Criteria Evidence for each Wave 4 Participant |  | 5d | 2026-02-23 | 2026-02-27 | 1943FF, 1947 | 2026-02-23 | 2026-02-27 | 5d |  |  | 4d | 0d | start no earlier than 2026-01-05 |  | Non-SIT S&A QT Test Team | Non-SIT S&A QT Test Team | 493.33 | 6.1 | Laura Kennedy | Green | GREEN |  |  |  |  |
| 1956 | 1.6.4.5.3.2 | Qualification Wave 4 Participant Test Readiness Confirmed | milestone | 0d | 2026-02-27 | 2026-02-27 | 1947, 1955, 1832, 1833 | 2026-02-27 | 2026-02-27 | 0d |  |  | 4d | 0d |  |  | Non-SIT S&A QT Test Team | Non-SIT S&A QT Test Team | 497.71 | 6.1 | Laura Kennedy | Green | GREEN | T3-QU-0043 | QAG |  |  |
| 1957 | 1.6.4.5.3.3 | Qualification Wave 4 QT Execution Start | milestone | 0d | 2026-03-02 | 2026-03-02 | 1956FS+1d, 1953 | 2026-03-02 | 2026-03-02 | 0d |  |  | 4d | 0d | start no earlier than 2026-01-07 |  | Participants | Participants | 500.71 | 6.1 | Laura Kennedy | Green | AMBER | T3-QU-0044 | QAG |  |  |
| 1958 | 1.6.4.5.3.4 | Qualification Wave 4 QT Execution Window |  | 95d | 2026-03-02 | 2026-07-10 | 1957FS-1d, 1955 | 2026-03-02 | 2026-07-10 | 96d |  |  | 9d | 0d |  |  | Participants | Participants | 500.33 | 6.1 | Laura Kennedy | Green | GREEN |  |  |  |  |
| 1959 | 1.6.4.5.3.5 | Qualification Wave 4 Projected Execution End | milestone | 0d | 2026-07-10 | 2026-07-10 | 1958 | 2026-07-10 | 2026-07-10 | 0d |  |  | 9d | 5d |  |  | Participants | Participants | 630.71 | 6.1 | Laura Kennedy | Green | GREEN | T3-QU-0057 | QAG |  |  |
| 1960 | 1.6.4.5.4 | **Qualification Wave 4 Exit** |  | 145d | 2026-03-02 | 2026-09-18 |  | 2026-03-02 | 2026-09-18 | 150d |  |  | 4d |  |  | -0 | N/A | N/A | -155.67 | 6.1 | N/A |  |  |  |  |  |  |
| 1961 | 1.6.4.5.4.1 | Final QAD Submission window opens | milestone | 0d | 2026-03-02 | 2026-03-02 | 1957 | 2026-03-02 | 2026-03-02 | 0d |  |  | 4d | 0d |  |  | Participants | Participants | 500.71 | 6.1 | Laura Kennedy | Green | GREEN |  |  |  |  |
| 1962 | 1.6.4.5.4.2 | Qualification Wave 4 Participants submit their Final QAD |  | 100d | 2026-03-02 | 2026-07-17 | 1961FS-1d | 2026-03-02 | 2026-07-17 | 101d |  |  | 4d | 0d |  |  | Participants | Participants | 500.33 | 6.1 | Laura Kennedy | Green | GREEN |  |  |  |  |
| 1963 | 1.6.4.5.4.3 | Qualification Wave 4 Participants have submitted their Final QAD | milestone | 0d | 2026-07-17 | 2026-07-17 | 1962, 1959 | 2026-07-17 | 2026-07-17 | 0d |  |  | 4d | 0d |  |  | Participants | Participants | 637.71 | 6.1 | Laura Kennedy | Green | GREEN | T3-QU-0109 | QAG |  |  |
| 1964 | 1.6.4.5.4.4 | Completion of Code Bodies review of Final QAD |  | 20d | 2026-07-20 | 2026-08-14 | 1963 | 2026-07-20 | 2026-08-14 | 25d |  |  | 4d | 0d |  |  | Code Bodies | Code Bodies | 640.33 | 6.1 | Laura Kennedy | Green | GREEN |  |  |  |  |
| 1965 | 1.6.4.5.4.5 | QAD Sign Off deadline |  | 1d | 2026-08-21 | 2026-08-21 | 1964FS+4d | 2026-08-21 | 2026-08-21 | 1d |  |  | 4d | 0d |  |  | Participants | Participants | 672.33 | 6.1 | Laura Kennedy | Green | GREEN |  |  |  |  |
| 1966 | 1.6.4.5.4.6 | Qualification Wave 4 Participants Qualification approved by BSC PAB and REC Manager | milestone | 0d | 2026-09-18 | 2026-09-18 | 1965FS+20d | 2026-09-18 | 2026-09-18 | 0d |  |  | 4d | 0d |  |  | Code Bodies | Code Bodies | 700.71 | 6.1 | Laura Kennedy | Green | GREEN | T2-QU-0300 | QAG |  |  |
| 1967 | 1.6.4.5.5 | **Qualification Tier 1 Milestone** |  | 66d | 2026-10-28 | 2027-01-28 |  | 2026-10-28 | 2027-01-28 |  |  |  | 235d |  |  |  |  |  | -686.67 |  |  | Overdue Start | RED |  |  |  |  |
| 1968 | 1.6.4.5.5.1 | All suppliers must be able to access MPANs under the new TOM (M14) | milestone | 0d | 2026-10-28 | 2026-10-28 | 1966FS+28d | 2026-10-28 | 2026-10-28 | 0d | 2026-03-16 | 2026-03-16 | 235d | 0d | start no earlier than 2026-03-12 |  | CPT | CPT | 740.71 | 6.1 | CPT | Green | GREEN | T1-MI-5000 | PSG | Migration | T1 |
| 1969 | 1.6.4.5.5.2 | All suppliers must be able to access MPANs under the new TOM (M14*) - Late Exit | milestone | 0d | 2027-01-28 | 2027-01-28 | 1968FS+66d | 2027-01-28 | 2027-01-28 | 0d | 2026-06-16 | 2026-06-16 | 235d |  |  |  | CPT | CPT | 832.71 | 6.1 | CPT | Green | GREEN | T1-MI-5500 | PSG | Migration | T1 |

Notes:
- 1957: 6/8/24: Date at risk from scenario planning activity
- 1966: 14/5: Baseline and name updated after cr48 approval at psg on 1/5
- 1968: Text3: All suppliers must be able to accept MPANs under the new TOM (one way gate)
- 1969: Text3: All suppliers must be able to accept MPANs under the new TOM (one way gate)

| ID | WBS | Task | Type | Duration | Start | Finish | Predecessors | Complete | Remaining | Baseline start | Baseline finish | Baseline duration | Baseline 1 start | Baseline 1 finish | Total slack | Constraint | Baseline cost | Responsible | Involved | MHHS Resource Name | MHHS Programme Phase | Update Version | Sched Status | RAG | Task Status | Artefact ID | Milestone ID | Text29 | Tier |
| --- | --- | --- | --- | --- | --- | --- | --- | --- | --- | --- | --- | --- | --- | --- | --- | --- | --- | --- | --- | --- | --- | --- | --- | --- | --- | --- | --- | --- | --- |
| 1970 | 1.7 | **REGULATORY** |  | 823d | 2022-10-31 A | 2025-12-24 |  | 93% | 54.4d | 2022-10-31 | 2025-12-24 | 680d | 2022-10-31 | 2025-03-07 | 521d |  | -0 | N/A | N/A | N/A | Regulatory |  |  |  |  |  |  |  |  |
| 1971 | 1.7.1 | **Baseline MHHS Code Changes** |  | 475d | 2022-10-31 A | 2024-08-23 A |  | 100% |  | 2022-10-31 | 2024-08-23 | 475d | 2022-10-31 | 2024-08-23 |  |  | -0 | N/A | N/A | N/A | Regulatory | 5.0 |  |  |  |  |  |  |  |
| 1972 | 1.7.1.1 | **Preparation and planning** |  | 35d | 2022-10-31 A | 2022-12-16 A |  | 100% |  | 2022-10-31 | 2022-12-16 | 35d | 2022-10-31 | 2022-12-16 |  |  |  | N/A | N/A | N/A | Regulatory | 5.0 |  |  |  |  |  |  |  |
| 1973 | 1.7.1.1.1 | Impact assessment of Programme design on codes to determine required changes |  | 20d | 2022-10-31 A | 2022-11-25 A | 47 | 100% |  | 2022-10-31 | 2022-11-25 | 20d | 2022-10-31 | 2022-11-25 |  |  |  | Code Bodies,SRO Code Drafters | Code Drafting PM | Andrew Margan | Regulatory | 5.0 | Complete | COMPLETE |  |  |  |  |  |
| 1974 | 1.7.1.1.2 | Become 'code draft ready' |  | 35d | 2022-10-31 A | 2022-12-16 A |  | 100% |  | 2022-10-31 | 2022-12-16 | 35d | 2022-10-31 | 2022-12-16 |  |  |  | Code Bodies,SRO Code Drafters | Code Drafting PM | Andrew Margan | Regulatory | 5.0 | Complete | COMPLETE |  |  |  |  |  |
| 1975 | 1.7.1.1.3 | Soft start drafting where possible |  | 35d | 2022-10-31 A | 2022-12-16 A |  | 100% |  | 2022-10-31 | 2022-12-16 | 35d | 2022-10-31 | 2022-12-16 |  |  |  | Code Bodies,SRO Code Drafters | Code Drafting PM | Andrew Margan | Regulatory | 5.0 | Complete | COMPLETE |  |  |  |  |  |
| 1976 | 1.7.1.2 | **Code drafting** |  | 443d | 2022-12-12 A | 2024-08-21 A |  | 100% |  | 2022-12-12 | 2024-08-21 | 445d | 2022-12-12 | 2024-08-23 |  |  | -0 | N/A | N/A | N/A | Regulatory | 5.0 |  |  | M6 |  |  |  |  |
| 1977 | 1.7.1.2.1 | **Data Services (BSC driven)** |  | 118d | 2022-12-12 A | 2023-05-24 A |  | 100% |  | 2022-12-12 | 2023-05-24 | 118d | 2022-12-12 | 2023-05-24 |  |  |  | N/A | N/A | N/A | Regulatory | 5.0 |  |  | M6 |  |  |  |  |
| 1978 | 1.7.1.2.1.1 | Pre Code Drafting activities |  | 5d | 2022-12-12 A | 2022-12-16 A |  | 100% |  | 2022-12-12 | 2022-12-16 | 5d | 2022-12-12 | 2022-12-16 |  | start no earlier than 2022-12-12 |  | Code Drafting PM |  | Andrew Margan | Regulatory | 5.0 | Complete | COMPLETE |  |  |  |  |  |
| 1979 | 1.7.1.2.1.2 | Code and subsidiary document drafting takes place offline |  | 19d | 2023-01-03 A | 2023-01-27 A | 1978FS+11d | 100% |  | 2023-01-03 | 2023-01-27 | 19d | 2023-01-03 | 2023-01-27 |  |  |  | Code Bodies,SRO Design | Code Drafting PM | Andrew Margan | Regulatory | 5.0 | Complete | COMPLETE |  |  |  |  |  |
| 1980 | 1.7.1.2.1.3 | Internal review and cross-checking of drafting across code drafters |  | 11d | 2023-01-30 A | 2023-02-13 A | 1979 | 100% |  | 2023-01-30 | 2023-02-13 | 11d | 2023-01-30 | 2023-02-13 |  |  |  | Code Bodies,SRO Design | Code Drafting PM | Andrew Margan | Regulatory | 5.0 | Complete | COMPLETE |  |  |  |  |  |
| 1981 | 1.7.1.2.1.4 | External industry review via consultation |  | 20d | 2023-02-14 A | 2023-03-13 A | 1980 | 100% |  | 2023-02-14 | 2023-03-13 | 20d | 2023-02-14 | 2023-03-13 |  |  |  | PP | Code Drafting PM | Andrew Margan | Regulatory | 5.0 | Complete | COMPLETE |  |  |  |  |  |
| 1982 | 1.7.1.2.1.5 | Triage and action comments |  | 19d | 2023-03-10 A | 2023-04-05 A | 1981FS-2d | 100% |  | 2023-03-10 | 2023-04-05 | 19d | 2023-03-10 | 2023-04-05 |  |  |  | Code Bodies,SRO Design | Code Drafting PM | Andrew Margan | Regulatory | 5.0 | Complete | COMPLETE |  |  |  |  |  |
| 1983 | 1.7.1.2.1.6 | CDWG review |  | 30d | 2023-04-06 A | 2023-05-17 A | 1982 | 100% |  | 2023-04-06 | 2023-05-17 | 30d | 2023-04-06 | 2023-05-17 |  |  |  | PP | Code Drafting PM | Andrew Margan | Regulatory | 5.0 | Complete | COMPLETE |  |  |  |  |  |
| 1984 | 1.7.1.2.1.7 | CCAG review |  | 5d | 2023-05-18 A | 2023-05-24 A | 1983 | 100% |  | 2023-05-18 | 2023-05-24 | 5d | 2023-05-18 | 2023-05-24 |  |  |  | PP |  | Andrew Margan | Regulatory | 5.0 | Complete | COMPLETE |  |  |  |  |  |
| 1985 | 1.7.1.2.1.8 | Code drafting for Data Services topic area approved | milestone | 0d | 2023-05-24 A | 2023-05-24 A | 1984 | 100% |  | 2023-05-24 | 2023-05-24 | 0d | 2023-05-24 | 2023-05-24 |  |  |  | PP | Code Drafting PM | Andrew Margan | Regulatory | 5.0 | Complete | COMPLETE |  | MHHS-ART060 | T2-RE-0100 | CCAG | T2 |
| 1986 | 1.7.1.2.2 | **Metering (REC driven)** |  | 118d | 2022-12-12 A | 2023-05-24 A |  | 100% |  | 2022-12-12 | 2023-05-24 | 118d | 2022-12-12 | 2023-05-24 |  |  |  | N/A | N/A | N/A | Regulatory | 5.0 |  |  | M6 |  |  |  |  |
| 1987 | 1.7.1.2.2.1 | Pre Code Drafting activities |  | 5d | 2022-12-12 A | 2022-12-16 A | 1978SS | 100% |  | 2022-12-12 | 2022-12-16 | 5d | 2022-12-12 | 2022-12-16 |  |  |  | Code Drafting PM |  | Andrew Margan | Regulatory | 5.0 | Complete | COMPLETE |  |  |  |  |  |
| 1988 | 1.7.1.2.2.2 | Code and subsidiary document drafting takes place offline |  | 19d | 2023-01-03 A | 2023-01-27 A | 1987FS+11d | 100% |  | 2023-01-03 | 2023-01-27 | 19d | 2023-01-03 | 2023-01-27 |  |  |  | Code Bodies,SRO Design | Code Drafting PM | Andrew Margan | Regulatory | 5.0 | Complete | COMPLETE |  |  |  |  |  |
| 1989 | 1.7.1.2.2.3 | Internal review and cross-checking of drafting across code drafters |  | 11d | 2023-01-30 A | 2023-02-13 A | 1988 | 100% |  | 2023-01-30 | 2023-02-13 | 11d | 2023-01-30 | 2023-02-13 |  |  |  | Code Bodies,SRO Design | Code Drafting PM | Andrew Margan | Regulatory | 5.0 | Complete | COMPLETE |  |  |  |  |  |
| 1990 | 1.7.1.2.2.4 | External industry review via consultation |  | 20d | 2023-02-14 A | 2023-03-13 A | 1989 | 100% |  | 2023-02-14 | 2023-03-13 | 20d | 2023-02-14 | 2023-03-13 |  |  |  | PP | Code Drafting PM | Andrew Margan | Regulatory | 5.0 | Complete | COMPLETE |  |  |  |  |  |
| 1991 | 1.7.1.2.2.5 | Triage and action comments |  | 19d | 2023-03-10 A | 2023-04-05 A | 1990FS-2d | 100% |  | 2023-03-10 | 2023-04-05 | 19d | 2023-03-10 | 2023-04-05 |  |  |  | Code Bodies,SRO Design | Code Drafting PM | Andrew Margan | Regulatory | 5.0 | Complete | COMPLETE |  |  |  |  |  |
| 1992 | 1.7.1.2.2.6 | CDWG review |  | 30d | 2023-04-06 A | 2023-05-17 A | 1991 | 100% |  | 2023-04-06 | 2023-05-17 | 30d | 2023-04-06 | 2023-05-17 |  |  |  | PP | Code Drafting PM | Andrew Margan | Regulatory | 5.0 | Complete | COMPLETE |  |  |  |  |  |
| 1993 | 1.7.1.2.2.7 | CCAG review |  | 5d | 2023-05-18 A | 2023-05-24 A | 1992 | 100% |  | 2023-05-18 | 2023-05-24 | 5d | 2023-05-18 | 2023-05-24 |  |  |  | PP |  | Andrew Margan | Regulatory | 5.0 | Complete | COMPLETE |  |  |  |  |  |
| 1994 | 1.7.1.2.2.8 | Code drafting for Metering topic area approved | milestone | 0d | 2023-05-24 A | 2023-05-24 A | 1993 | 100% |  | 2023-05-24 | 2023-05-24 | 0d | 2023-05-24 | 2023-05-24 |  |  |  | PP | Code Drafting PM | Andrew Margan | Regulatory | 5.0 | Complete | COMPLETE |  | MHHS-ART060 | T2-RE-0150 | CCAG | T2 |

| ID | WBS | Task | Type | Duration | Start | Finish | Predecessors | Complete | Baseline start | Baseline finish | Baseline duration | Baseline 1 start | Baseline 1 finish | Constraint | Responsible | Involved | Task Status | Update Version | MHHS Resource Name | MHHS Programme Phase | Sched Status | RAG | Artefact ID | Milestone ID | Text29 | Tier |
| --- | --- | --- | --- | --- | --- | --- | --- | --- | --- | --- | --- | --- | --- | --- | --- | --- | --- | --- | --- | --- | --- | --- | --- | --- | --- | --- |
| 1995 | 1.7.1.2.3 | **BSC Central Services (BSC driven)** |  | 156d | 2023-02-22 A | 2023-09-27 A |  | 100% | 2023-02-22 | 2023-09-27 | 156d | 2023-02-22 | 2023-09-14 |  | N/A | N/A | M6 | 5.0 | N/A | Regulatory |  |  |  |  |  |  |
| 1996 | 1.7.1.2.3.1 | Pre Code Drafting activities |  | 5d | 2023-02-22 A | 2023-02-28 A | 1997SS-5d | 100% | 2023-02-22 | 2023-02-28 | 5d | 2023-02-22 | 2023-02-28 |  | Code Drafting PM |  |  | 5.0 | Andrew Margan | Regulatory | Complete | COMPLETE |  |  |  |  |
| 1997 | 1.7.1.2.3.2 | Code Drafting (offline) |  | 80d | 2023-03-01 A | 2023-06-20 A | 1981SS | 100% | 2023-03-01 | 2023-06-20 | 80d | 2023-03-01 | 2023-06-20 | must start on 2023-03-01 | Code Bodies,SRO Design | Code Drafting PM |  | 5.0 | Andrew Margan | Regulatory | Complete | COMPLETE |  |  |  |  |
| 1998 | 1.7.1.2.3.3 | Internal review and cross-checking of drafting across code drafters |  | 70d | 2023-03-15 A | 2023-06-20 A | 1997SS+10d | 100% | 2023-03-15 | 2023-06-20 | 70d | 2023-03-15 | 2023-06-20 |  | Code Bodies,SRO Design | Code Drafting PM |  | 5.0 | Andrew Margan | Regulatory | Complete | COMPLETE |  |  |  |  |
| 1999 | 1.7.1.2.3.4 | External industry review via consultation |  | 15d | 2023-06-21 A | 2023-07-11 A | 1998 | 100% | 2023-06-21 | 2023-07-11 | 15d | 2023-06-21 | 2023-07-11 |  | PP | Code Drafting PM |  | 5.0 | Andrew Margan | Regulatory | Complete | COMPLETE |  |  |  |  |
| 2000 | 1.7.1.2.3.5 | Triage and action comments |  | 19d | 2023-07-10 A | 2023-08-03 A | 1999FS-2d | 100% | 2023-07-10 | 2023-08-03 | 19d | 2023-07-10 | 2023-08-03 |  | Code Bodies,SRO Design | Code Drafting PM |  | 5.0 | Andrew Margan | Regulatory | Complete | COMPLETE |  |  |  |  |
| 2001 | 1.7.1.2.3.6 | CDWG review |  | 28d | 2023-08-04 A | 2023-09-12 A | 2000 | 100% | 2023-08-04 | 2023-09-12 | 28d | 2023-08-04 | 2023-09-07 |  | PP | Code Drafting PM |  | 5.0 | Andrew Margan | Regulatory | Complete | COMPLETE |  |  |  |  |
| 2002 | 1.7.1.2.3.7 | CCAG review |  | 11d | 2023-09-13 A | 2023-09-27 A | 2001 | 100% | 2023-09-13 | 2023-09-27 | 11d | 2023-09-08 | 2023-09-14 |  | PP |  |  | 5.0 | Andrew Margan | Regulatory | Complete | COMPLETE |  |  |  |  |
| 2003 | 1.7.1.2.3.8 | Code drafting for BSC Central Services topic area approved | milestone | 0d | 2023-09-27 A | 2023-09-27 A | 2002 | 100% | 2023-09-27 | 2023-09-27 | 0d | 2023-09-14 | 2023-09-14 |  | PP | Code Drafting PM |  | 5.0 | Andrew Margan | Regulatory | Complete | COMPLETE | MHHS-ART060 | T2-RE-0200 | CCAG | T2 |
| 2004 | 1.7.1.2.4 | **Registration (BSC & REC driven)** |  | 131d | 2023-02-22 A | 2023-08-23 A |  | 100% | 2023-02-22 | 2023-08-23 | 131d | 2023-02-22 | 2023-08-23 |  | N/A | N/A | M6 | 5.0 | N/A | Regulatory |  |  |  |  |  |  |
| 2005 | 1.7.1.2.4.1 | Pre Code Drafting activities |  | 5d | 2023-02-22 A | 2023-02-28 A | 2006SS-5d | 100% | 2023-02-22 | 2023-02-28 | 5d | 2023-02-22 | 2023-02-28 |  | Code Drafting PM |  |  | 5.0 | Andrew Margan | Regulatory | Complete | COMPLETE |  |  |  |  |
| 2006 | 1.7.1.2.4.2 | Code Drafting (offline) |  | 65d | 2023-03-01 A | 2023-05-30 A | 1980, 1989 | 100% | 2023-03-01 | 2023-05-30 | 65d | 2023-03-01 | 2023-05-30 | must start on 2023-03-01 | Code Bodies,SRO Design | Code Drafting PM |  | 5.0 | Andrew Margan | Regulatory | Complete | COMPLETE |  |  |  |  |
| 2007 | 1.7.1.2.4.3 | Internal review and cross-checking of drafting across code drafters |  | 55d | 2023-03-15 A | 2023-05-30 A | 2006SS+10d | 100% | 2023-03-15 | 2023-05-30 | 55d | 2023-03-15 | 2023-05-30 |  | Code Bodies,SRO Design | Code Drafting PM |  | 5.0 | Andrew Margan | Regulatory | Complete | COMPLETE |  |  |  |  |
| 2008 | 1.7.1.2.4.4 | External industry review via consultation |  | 15d | 2023-05-31 A | 2023-06-20 A | 2007 | 100% | 2023-05-31 | 2023-06-20 | 15d | 2023-05-31 | 2023-06-20 |  | PP | Code Drafting PM |  | 5.0 | Andrew Margan | Regulatory | Complete | COMPLETE |  |  |  |  |
| 2009 | 1.7.1.2.4.5 | Triage and action comments |  | 19d | 2023-06-19 A | 2023-07-13 A | 2008FS-2d | 100% | 2023-06-19 | 2023-07-13 | 19d | 2023-06-19 | 2023-07-13 |  | Code Bodies,SRO Design | Code Drafting PM |  | 5.0 | Andrew Margan | Regulatory | Complete | COMPLETE |  |  |  |  |
| 2010 | 1.7.1.2.4.6 | CDWG review |  | 18d | 2023-07-14 A | 2023-08-08 A | 2009 | 100% | 2023-07-14 | 2023-08-08 | 18d | 2023-07-14 | 2023-08-16 |  | PP | Code Drafting PM |  | 5.0 | Andrew Margan | Regulatory | Complete | COMPLETE |  |  |  |  |
| 2011 | 1.7.1.2.4.7 | CCAG review |  | 11d | 2023-08-09 A | 2023-08-23 A | 2010 | 100% | 2023-08-09 | 2023-08-23 | 11d | 2023-08-17 | 2023-08-23 |  | PP |  |  | 5.0 | Andrew Margan | Regulatory | Complete | COMPLETE |  |  |  |  |
| 2012 | 1.7.1.2.4.8 | Code drafting for Registration topic area approved | milestone | 0d | 2023-08-23 A | 2023-08-23 A | 2011 | 100% | 2023-08-23 | 2023-08-23 | 0d | 2023-08-23 | 2023-08-23 |  | PP | Code Drafting PM |  | 5.0 | Andrew Margan | Regulatory | Complete | COMPLETE | MHHS-ART060 | T2-RE-0250 | CCAG | T2 |
| 2013 | 1.7.1.2.5 | **Governance and Qualification (BSC & REC driven)** |  | 130d | 2023-05-25 A | 2023-11-22 A |  | 100% | 2023-05-25 | 2023-11-22 | 130d | 2023-05-25 | 2023-11-13 |  | N/A | N/A | M6 | 5.0 | N/A | Regulatory |  |  |  |  |  |  |
| 2014 | 1.7.1.2.5.1 | Pre Code Drafting activities |  | 5d | 2023-05-25 A | 2023-05-31 A | 2015SS-5d | 100% | 2023-05-25 | 2023-05-31 | 5d | 2023-05-25 | 2023-05-31 |  | Code Drafting PM |  |  | 5.0 | Andrew Margan | Regulatory | Complete | COMPLETE |  |  |  |  |
| 2015 | 1.7.1.2.5.2 | Code Drafting (offline) |  | 55d | 2023-06-01 A | 2023-08-16 A | 2008SS+1d | 100% | 2023-06-01 | 2023-08-16 | 55d | 2023-06-01 | 2023-08-16 |  | Code Bodies,SRO Design | Code Drafting PM |  | 5.0 | Andrew Margan | Regulatory | Complete | COMPLETE |  |  |  |  |
| 2016 | 1.7.1.2.5.3 | Internal review and cross-checking of drafting across code drafters |  | 45d | 2023-06-15 A | 2023-08-16 A | 2015SS+10d | 100% | 2023-06-15 | 2023-08-16 | 45d | 2023-06-15 | 2023-08-16 |  | Code Bodies,SRO Design | Code Drafting PM |  | 5.0 | Andrew Margan | Regulatory | Complete | COMPLETE |  |  |  |  |
| 2017 | 1.7.1.2.5.4 | External industry review via consultation |  | 15d | 2023-08-18 A | 2023-09-07 A | 2016FS+1d | 100% | 2023-08-18 | 2023-09-07 | 15d | 2023-08-18 | 2023-09-07 |  | PP | Code Drafting PM |  | 5.0 | Andrew Margan | Regulatory | Complete | COMPLETE |  |  |  |  |
| 2018 | 1.7.1.2.5.5 | Triage and action comments |  | 19d | 2023-09-06 A | 2023-10-02 A | 2017FS-2d | 100% | 2023-09-06 | 2023-10-02 | 19d | 2023-09-06 | 2023-10-02 |  | Code Bodies,SRO Design | Code Drafting PM |  | 5.0 | Andrew Margan | Regulatory | Complete | COMPLETE |  |  |  |  |
| 2019 | 1.7.1.2.5.6 | CDWG review |  | 31d | 2023-10-03 A | 2023-11-14 A | 2018 | 100% | 2023-10-03 | 2023-11-14 | 31d | 2023-10-03 | 2023-11-06 |  | PP | Code Drafting PM |  | 5.0 | Andrew Margan | Regulatory | Complete | COMPLETE |  |  |  |  |
| 2020 | 1.7.1.2.5.7 | CCAG review |  | 6d | 2023-11-15 A | 2023-11-22 A | 2019 | 100% | 2023-11-15 | 2023-11-22 | 6d | 2023-11-07 | 2023-11-13 |  | PP |  |  | 5.0 | Andrew Margan | Regulatory | Complete | COMPLETE |  |  |  |  |
| 2021 | 1.7.1.2.5.8 | Code drafting for Governance and Qualification topic areas approved | milestone | 0d | 2023-11-22 A | 2023-11-22 A | 2020 | 100% | 2023-11-22 | 2023-11-22 | 0d | 2023-11-13 | 2023-11-13 |  | PP | Code Drafting PM |  | 5.12 | Andrew Margan | Regulatory | Complete | COMPLETE | MHHS-ART060 | T3-RE-0300 | CCAG | T2 |

Notes:
- 2021: 10/10 - CH - Agreed at PSG on 4/10 to downgrade from T2 to T3

| ID | WBS | Task | Type | Duration | Start | Finish | Predecessors | Complete | Baseline start | Baseline finish | Baseline duration | Baseline 1 start | Baseline 1 finish | Constraint | Baseline cost | Responsible | Involved | Task Status | Update Version | MHHS Resource Name | MHHS Programme Phase | Sched Status | RAG | Artefact ID | Milestone ID | Text29 | Tier |
| --- | --- | --- | --- | --- | --- | --- | --- | --- | --- | --- | --- | --- | --- | --- | --- | --- | --- | --- | --- | --- | --- | --- | --- | --- | --- | --- | --- |
| 2022 | 1.7.1.2.6 | **Interfaces / Data Specification (REC driven)** |  | 174d | 2023-05-25 A | 2024-01-23 A |  | 100% | 2023-05-25 | 2024-01-23 | 175d | 2023-05-25 | 2023-11-13 |  |  | N/A | N/A | M6 | 5.2 | N/A | Regulatory |  |  |  |  |  |  |
| 2023 | 1.7.1.2.6.1 | Pre Code Drafting activities |  | 5d | 2023-05-25 A | 2023-05-31 A | 2024SS-5d | 100% | 2023-05-25 | 2023-05-31 | 5d | 2023-05-25 | 2023-05-31 |  |  | Code Drafting PM |  |  | 5.0 | Andrew Margan | Regulatory | Complete | COMPLETE |  |  |  |  |
| 2024 | 1.7.1.2.6.2 | Code Drafting (offline) |  | 94d | 2023-06-01 A | 2023-10-10 A | 2008SS+1d | 100% | 2023-06-01 | 2023-10-10 | 94d | 2023-06-01 | 2023-08-16 |  |  | Code Bodies,SRO Design | Code Drafting PM |  | 5.2 | Andrew Margan | Regulatory | Complete | COMPLETE |  |  |  |  |
| 2025 | 1.7.1.2.6.3 | Internal review and cross-checking of drafting across code drafters |  | 84d | 2023-06-15 A | 2023-10-10 A | 2024SS+10d | 100% | 2023-06-15 | 2023-10-10 | 84d | 2023-06-15 | 2023-08-16 |  |  | Code Bodies,SRO Design | Code Drafting PM |  | 5.2 | Andrew Margan | Regulatory | Complete | COMPLETE |  |  |  |  |
| 2026 | 1.7.1.2.6.4 | External industry review via consultation |  | 15d | 2023-10-11 A | 2023-10-31 A | 2025 | 100% | 2023-10-11 | 2023-10-31 | 15d | 2023-08-18 | 2023-09-07 |  |  | PP | Code Drafting PM |  | 5.2 | Andrew Margan | Regulatory | Complete | COMPLETE |  |  |  |  |
| 2027 | 1.7.1.2.6.5 | Triage and action comments |  | 20d | 2023-10-30 A | 2023-11-24 A | 2026FS-2d | 100% | 2023-10-30 | 2023-11-24 | 20d | 2023-09-06 | 2023-10-02 |  |  | Code Bodies,SRO Design | Code Drafting PM |  | 5.2 | Andrew Margan | Regulatory | Complete | COMPLETE |  |  |  |  |
| 2028 | 1.7.1.2.6.6 | CDWG review |  | 37d | 2023-11-27 A | 2024-01-16 A | 2027 | 100% | 2023-11-27 | 2024-01-16 | 32d | 2023-10-03 | 2023-11-06 |  |  | PP | Code Drafting PM |  | 5.2 | Andrew Margan | Regulatory | Complete | COMPLETE |  |  |  |  |
| 2029 | 1.7.1.2.6.7 | CCAG review |  | 5d | 2024-01-17 A | 2024-01-23 A | 2028 | 100% | 2024-01-17 | 2024-01-23 | 11d | 2023-11-07 | 2023-11-13 |  |  | PP | Code Drafting PM |  | 5.2 | Andrew Margan | Regulatory | Complete | COMPLETE |  |  |  |  |
| 2030 | 1.7.1.2.6.8 | Code drafting for Interfaces / Data Specification topic areas approved | milestone | 0d | 2024-01-23 A | 2024-01-23 A | 2029 | 100% | 2024-01-23 | 2024-01-23 | 0d | 2023-11-13 | 2023-11-13 |  |  | PP | Code Drafting PM |  | 5.16 | Andrew Margan | Regulatory | Complete | COMPLETE | MHHS-ART060 | T3-RE-0350 | CCAG | T2 |
| 2031 | 1.7.1.2.7 | **Migration (BSC & REC driven)** |  | 130d | 2023-05-25 A | 2023-11-22 A |  | 100% | 2023-05-25 | 2023-11-22 | 130d | 2023-05-25 | 2023-11-13 |  |  | N/A | N/A | M6 | 5.0 | N/A | Regulatory |  |  |  |  |  |  |
| 2032 | 1.7.1.2.7.1 | Pre Code Drafting activities |  | 5d | 2023-05-25 A | 2023-05-31 A | 2033SS-5d | 100% | 2023-05-25 | 2023-05-31 | 5d | 2023-05-25 | 2023-05-31 |  |  | Code Drafting PM |  |  | 5.0 | Andrew Margan | Regulatory | Complete | COMPLETE |  |  |  |  |
| 2033 | 1.7.1.2.7.2 | Code Drafting (offline) |  | 55d | 2023-06-01 A | 2023-08-16 A | 2008SS+1d | 100% | 2023-06-01 | 2023-08-16 | 55d | 2023-06-01 | 2023-08-16 |  |  | Code Bodies,SRO Design | Code Drafting PM |  | 5.0 | Andrew Margan | Regulatory | Complete | COMPLETE |  |  |  |  |
| 2034 | 1.7.1.2.7.3 | Internal review and cross-checking of drafting across code drafters |  | 45d | 2023-06-15 A | 2023-08-16 A | 2033SS+10d | 100% | 2023-06-15 | 2023-08-16 | 45d | 2023-06-15 | 2023-08-16 |  |  | Code Bodies,SRO Design | Code Drafting PM |  | 5.0 | Andrew Margan | Regulatory | Complete | COMPLETE |  |  |  |  |
| 2035 | 1.7.1.2.7.4 | External industry review via consultation |  | 15d | 2023-08-18 A | 2023-09-07 A | 2034FS+1d | 100% | 2023-08-18 | 2023-09-07 | 15d | 2023-08-18 | 2023-09-07 |  |  | PP | Code Drafting PM |  | 5.0 | Andrew Margan | Regulatory | Complete | COMPLETE |  |  |  |  |
| 2036 | 1.7.1.2.7.5 | Triage and action comments |  | 19d | 2023-09-06 A | 2023-10-02 A | 2035FS-2d | 100% | 2023-09-06 | 2023-10-02 | 19d | 2023-09-06 | 2023-10-02 |  |  | Code Bodies,SRO Design | Code Drafting PM |  | 5.0 | Andrew Margan | Regulatory | Complete | COMPLETE |  |  |  |  |
| 2037 | 1.7.1.2.7.6 | CDWG review |  | 31d | 2023-10-03 A | 2023-11-14 A | 2036 | 100% | 2023-10-03 | 2023-11-14 | 31d | 2023-10-03 | 2023-11-06 |  |  | PP | Code Drafting PM |  | 5.0 | Andrew Margan | Regulatory | Complete | COMPLETE |  |  |  |  |
| 2038 | 1.7.1.2.7.7 | CCAG review |  | 6d | 2023-11-15 A | 2023-11-22 A | 2037 | 100% | 2023-11-15 | 2023-11-22 | 6d | 2023-11-07 | 2023-11-13 |  |  | PP | Code Drafting PM |  | 5.0 | Andrew Margan | Regulatory | Complete | COMPLETE |  |  |  |  |
| 2039 | 1.7.1.2.7.8 | Code drafting for Migration topic area approved | milestone | 0d | 2023-11-22 A | 2023-11-22 A | 2038 | 100% | 2023-11-22 | 2023-11-22 | 0d | 2023-11-13 | 2023-11-13 |  |  | PP | Code Drafting PM |  | 5.12 | Andrew Margan | Regulatory | Complete | COMPLETE | MHHS-ART060 | T3-RE-0400 | CCAG | T2 |
| 2040 | 1.7.1.2.8 | **Consequential Code Change** |  | 109d | 2023-10-11 A | 2024-03-11 A |  | 100% | 2023-10-11 | 2024-03-11 | 108d | 2023-08-18 | 2024-03-08 |  | -0 | N/A | N/A |  | 5.0 | N/A | Regulatory |  |  |  |  |  |  |
| 2041 | 1.7.1.2.8.1 | External industry review via consultation - drop 1 (DCUSA) |  | 15d | 2023-10-11 A | 2023-10-31 A | 2047SS | 100% | 2023-10-11 | 2023-10-31 | 15d | 2023-08-18 | 2023-09-07 |  |  | Code Bodies | PP |  | 5.2 | Andrew Margan | Regulatory | Complete | COMPLETE |  |  |  |  |
| 2042 | 1.7.1.2.8.2 | External industry review via consultation - drop 2 (Elexon) |  | 16d | 2024-02-19 A | 2024-03-11 A | 2057SS | 100% | 2024-02-19 | 2024-03-11 | 15d | 2023-10-16 | 2023-11-03 | start no earlier than 2024-02-19 |  | Code Bodies | PP |  | 5.2 | Andrew Margan | Regulatory | Complete | COMPLETE |  |  |  |  |
| 2043 | 1.7.1.2.9 | **Transition Text (all codes)** |  | 118d | 2023-08-11 A | 2024-01-23 A |  | 100% | 2023-08-11 | 2024-01-23 | 119d | 2023-08-11 | 2024-01-25 |  |  | N/A | N/A | M6 | 5.2 | N/A | Regulatory |  |  |  |  |  |  |
| 2044 | 1.7.1.2.9.1 | Pre Code Drafting activities |  | 8d | 2023-08-11 A | 2023-08-22 A | 2045SS-5d | 100% | 2023-08-11 | 2023-08-22 | 8d | 2023-08-11 | 2023-08-17 |  |  | Code Drafting PM |  |  | 5.0 | Andrew Margan | Regulatory | Complete | COMPLETE |  |  |  |  |
| 2045 | 1.7.1.2.9.2 | Code Drafting (offline) |  | 38d | 2023-08-18 A | 2023-10-10 A | 2035SS | 100% | 2023-08-18 | 2023-10-10 | 38d | 2023-08-18 | 2023-10-12 |  |  | Code Bodies,SRO Design | Code Drafting PM |  | 5.2 | Andrew Margan | Regulatory | Complete | COMPLETE |  |  |  |  |
| 2046 | 1.7.1.2.9.3 | Internal review and cross-checking of drafting across code drafters |  | 28d | 2023-09-01 A | 2023-10-10 A | 2045SS+10d | 100% | 2023-09-01 | 2023-10-10 | 28d | 2023-09-01 | 2023-10-12 |  |  | Code Bodies,SRO Design | Code Drafting PM |  | 5.2 | Andrew Margan | Regulatory | Complete | COMPLETE |  |  |  |  |
| 2047 | 1.7.1.2.9.4 | External industry review via consultation |  | 15d | 2023-10-11 A | 2023-10-31 A | 2046 | 100% | 2023-10-11 | 2023-10-31 | 15d | 2023-10-16 | 2023-11-03 |  |  | PP | Code Drafting PM |  | 5.2 | Andrew Margan | Regulatory | Complete | COMPLETE |  |  |  |  |
| 2048 | 1.7.1.2.9.5 | Triage and action comments |  | 20d | 2023-10-30 A | 2023-11-24 A | 2047FS-2d | 100% | 2023-10-30 | 2023-11-24 | 20d | 2023-11-02 | 2023-11-21 |  |  | Code Bodies,SRO Design | Code Drafting PM |  | 5.2 | Andrew Margan | Regulatory | Complete | COMPLETE |  |  |  |  |
| 2049 | 1.7.1.2.9.6 | CDWG review |  | 37d | 2023-11-27 A | 2024-01-16 A | 2048 | 100% | 2023-11-27 | 2024-01-16 | 37d | 2023-11-22 | 2024-01-17 |  |  | PP | Code Drafting PM |  | 5.2 | Andrew Margan | Regulatory | Complete | COMPLETE |  |  |  |  |
| 2050 | 1.7.1.2.9.7 | CCAG review |  | 5d | 2024-01-17 A | 2024-01-23 A | 2049 | 100% | 2024-01-17 | 2024-01-23 | 6d | 2024-01-18 | 2024-01-25 |  |  | PP | Code Drafting PM |  | 5.2 | Andrew Margan | Regulatory | Complete | COMPLETE |  |  |  |  |
| 2051 | 1.7.1.2.9.8 | Code drafting for Transition Text topic area approved | milestone | 0d | 2024-01-23 A | 2024-01-23 A | 2050 | 100% | 2024-01-23 | 2024-01-23 | 0d | 2024-01-25 | 2024-01-25 |  |  | PP | Code Drafting PM |  | 5.16 | Andrew Margan | Regulatory | Complete | COMPLETE | MHHS-ART060 | T3-RE-0450 | CCAG | T2 |

Notes:
- 2030: 10/10 - CH - Agreed at PSG on 4/10 to downgrade from T2 to T3
- 2039: 31/07/23 - Changed date to 22/11/23 from 13/11/23 after approval from CCAG on 28/6/23. 10/10 - CH - Agreed at PSG on 4/10 to downgrade from T2 to T3
- 2041: Review of drop schedule and scope is being undertaken with CCAG.
- 2042: Review of drop schedule and scope is being undertaken with CCAG.
- 2045: Guidance: 14/8/23 - RECCo transition drafting activity is expected to take the full 38 days, noting BSE co-drafting will be expected to take approx. 21 days
- 2051: 10/10 - CH - Agreed at PSG on 4/10 to downgrade from T2 to T3

| ID | WBS | Task | Type | Duration | Start | Finish | Predecessors | Complete | Remaining | Baseline start | Baseline finish | Baseline duration | Baseline 1 start | Baseline 1 finish | Total slack | Free slack | Baseline cost | Responsible | Involved | Task Status | Update Version | MHHS Resource Name | MHHS Programme Phase | Sched Status | RAG | Artefact ID | Milestone ID | Text29 | Tier |
| --- | --- | --- | --- | --- | --- | --- | --- | --- | --- | --- | --- | --- | --- | --- | --- | --- | --- | --- | --- | --- | --- | --- | --- | --- | --- | --- | --- | --- | --- |
| 2052 | 1.7.1.2.10 | **Final Code Drafting (mop-up) (all codes)** |  | 199d | 2023-08-18 A | 2024-05-22 A |  | 100% |  | 2023-08-18 | 2024-05-22 | 199d | 2023-08-18 | 2024-05-13 |  |  |  | N/A | N/A | M6 | 5.0 | N/A | Regulatory |  |  |  |  |  |  |
| 2053 | 1.7.1.2.10.1 | Forward look and confirm remaining plan |  | 15d | 2023-08-18 A | 2023-09-07 A | 2045SS | 100% |  | 2023-08-18 | 2023-09-07 | 15d | 2023-08-18 | 2023-09-07 |  |  |  | Code Drafting PM |  |  | 5.0 | Andrew Margan | Regulatory | Complete | COMPLETE |  |  |  |  |
| 2054 | 1.7.1.2.10.2 | Identify remaining or additional areas of code (e.g. consequential change requirements) to be completed |  | 15d | 2023-08-18 A | 2023-09-07 A | 2053SS | 100% |  | 2023-08-18 | 2023-09-07 | 15d | 2023-08-18 | 2023-09-07 |  |  |  | Code Bodies,SRO Design | Code Drafting PM |  | 5.0 | Andrew Margan | Regulatory | Complete | COMPLETE |  |  |  |  |
| 2055 | 1.7.1.2.10.3 | Code Drafting (offline) Interim Consultation (1) |  | 60d | 2023-09-08 A | 2023-11-30 A | 2054 | 100% |  | 2023-09-08 | 2023-11-30 | 60d | 2023-09-08 | 2024-02-15 |  |  |  | Code Bodies,SRO Design | Code Drafting PM |  | 5.0 | Andrew Margan | Regulatory | Complete | COMPLETE |  |  |  |  |
| 2056 | 1.7.1.2.10.4 | Internal review and cross-checking of drafting across code drafters Interim Consultation (1) |  | 50d | 2023-09-22 A | 2023-11-30 A | 2055SS+10d | 100% |  | 2023-09-22 | 2023-11-30 | 50d | 2023-09-22 | 2024-02-15 |  |  |  | Code Bodies,SRO Design | Code Drafting PM |  | 5.0 | Andrew Margan | Regulatory | Complete | COMPLETE |  |  |  |  |
| 2057 | 1.7.1.2.10.5 | External industry review via consultation Interim Consultation (1) |  | 23d | 2023-12-01 A | 2024-01-02 A | 2056 | 100% |  | 2023-12-01 | 2024-01-02 | 23d | 2024-02-19 | 2024-03-08 |  |  |  | PP | Code Drafting PM |  | 5.0 | Andrew Margan | Regulatory | Complete | COMPLETE |  |  |  |  |
| 2058 | 1.7.1.2.10.6 | Code Drafting (offline) Final Consultation (2) |  | 55d | 2023-12-01 A | 2024-02-15 A | 2056 | 100% |  | 2023-12-01 | 2024-02-15 | 55d | 2023-09-08 | 2024-02-15 |  |  |  | Code Bodies,SRO Design | Code Drafting PM |  | 5.0 | Andrew Margan | Regulatory | Complete | COMPLETE |  |  |  |  |
| 2059 | 1.7.1.2.10.7 | Internal review and cross-checking of drafting across code drafters Final Consultation (2) |  | 45d | 2023-12-15 A | 2024-02-15 A | 2058SS+10d | 100% |  | 2023-12-15 | 2024-02-15 | 45d | 2023-09-22 | 2024-02-15 |  |  |  | Code Bodies,SRO Design | Code Drafting PM |  | 5.0 | Andrew Margan | Regulatory | Complete | COMPLETE |  |  |  |  |
| 2060 | 1.7.1.2.10.8 | External industry review via consultation Final Consultation (2) |  | 16d | 2024-02-19 A | 2024-03-11 A | 2059FS+1d | 100% |  | 2024-02-19 | 2024-03-11 | 15d | 2024-02-19 | 2024-03-08 |  |  |  | PP | Code Drafting PM |  | 5.0 | Andrew Margan | Regulatory | Complete | COMPLETE |  |  |  |  |
| 2061 | 1.7.1.2.10.9 | Triage and action comments |  | 18d | 2024-03-11 A | 2024-04-03 A | 2060FS-1d | 100% |  | 2024-03-11 | 2024-04-03 | 18d | 2024-03-07 | 2024-04-03 |  |  |  | Code Bodies,SRO Design | Code Drafting PM |  | 5.0 | Andrew Margan | Regulatory | Complete | COMPLETE |  |  |  |  |
| 2062 | 1.7.1.2.10.10 | CDWG review |  | 29d | 2024-04-04 A | 2024-05-14 A | 2061 | 100% |  | 2024-04-04 | 2024-05-14 | 31d | 2024-04-04 | 2024-05-03 |  |  |  | PP | Code Drafting PM |  | 5.0 | Andrew Margan | Regulatory | Complete | COMPLETE |  |  |  |  |
| 2063 | 1.7.1.2.10.11 | CCAG review |  | 6d | 2024-05-15 A | 2024-05-22 A | 2062 | 100% |  | 2024-05-15 | 2024-05-22 | 6d | 2024-05-06 | 2024-05-13 |  |  |  | PP | Code Drafting PM |  | 5.0 | Andrew Margan | Regulatory | Complete | COMPLETE |  |  |  |  |
| 2064 | 1.7.1.2.10.12 | Final code drafting (mop-up) approved | milestone | 0d | 2024-05-22 A | 2024-05-22 A | 2063 | 100% |  | 2024-05-22 | 2024-05-22 | 0d | 2024-05-13 | 2024-05-13 |  |  |  | PP | Code Drafting PM |  | 5.25 | Andrew Margan | Regulatory | Complete | COMPLETE | MHHS-ART060 | T3-RE-0500 | CCAG | T2 |
| 2065 | 1.7.1.2.11 | **Final code review, consistency check and approval** |  | 100d | 2024-04-04 A | 2024-08-21 A |  | 100% |  | 2024-04-04 | 2024-08-21 | 102d | 2024-05-06 | 2024-08-23 |  |  | -0 | N/A | N/A | M6 | 5.0 | N/A | Regulatory |  |  |  |  |  |  |
| 2066 | 1.7.1.2.11.1 | Gap analysis of final code against design artefacts (reverse process to code drafting) |  | 38d | 2024-04-04 A | 2024-05-27 A | 2062SS | 100% |  | 2024-04-04 | 2024-05-27 | 38d | 2024-05-06 | 2024-05-17 |  |  |  | Code Bodies,SRO Design | Code Drafting PM |  | 5.0 | Andrew Margan | Regulatory | Complete | COMPLETE |  |  |  |  |
| 2067 | 1.7.1.2.11.2 | Outputs of gap analysis actioned offline |  | 11d | 2024-05-28 A | 2024-06-11 A | 2066 | 100% |  | 2024-05-28 | 2024-06-11 | 11d | 2024-05-20 | 2024-06-07 |  |  |  | Code Bodies,SRO Design | Code Drafting PM |  | 5.0 | Andrew Margan | Regulatory | Complete | COMPLETE |  |  |  |  |
| 2068 | 1.7.1.2.11.3 | Final documentation collated for final consultation |  | 8d | 2024-06-12 A | 2024-06-21 A | 2067 | 100% |  | 2024-06-12 | 2024-06-21 | 9d | 2024-06-10 | 2024-06-13 |  |  |  | Code Drafting PM | Code Bodies,SRO Design |  | 5.23 | Andrew Margan | Regulatory | Complete | COMPLETE |  |  |  |  |
| 2069 | 1.7.1.2.11.4 | External industry review via consultation |  | 15d | 2024-06-24 A | 2024-07-12 A | 2068 | 100% |  | 2024-06-24 | 2024-07-12 | 20d | 2024-06-14 | 2024-07-04 |  |  |  | PP | Code Drafting PM |  | 5.0 | Andrew Margan | Regulatory | Complete | COMPLETE |  |  |  |  |
| 2070 | 1.7.1.2.11.5 | Triage and action comments |  | 10d | 2024-07-15 A | 2024-07-26 A | 2069 | 100% |  | 2024-07-15 | 2024-07-26 | 13d | 2024-07-03 | 2024-07-19 |  |  |  | Code Bodies,SRO Design | Code Drafting PM |  | 5.0 | Andrew Margan | Regulatory | Complete | COMPLETE |  |  |  |  |
| 2071 | 1.7.1.2.11.6 | Final CDWG review |  | 8d | 2024-08-02 A | 2024-08-13 A | 2070FS+4d | 100% |  | 2024-08-02 | 2024-08-13 | 6d | 2024-07-22 | 2024-08-16 |  |  |  | PP | Code Drafting PM |  | 5.0 | Andrew Margan | Regulatory | Complete | COMPLETE |  |  |  |  |
| 2072 | 1.7.1.2.11.7 | Final CCAG review |  | 6d | 2024-08-14 A | 2024-08-21 A | 2071 | 100% |  | 2024-08-14 | 2024-08-21 | 8d | 2024-08-19 | 2024-08-23 |  |  |  | PP | Code Drafting PM |  | 5.0 | Andrew Margan | Regulatory | Complete | COMPLETE |  |  |  |  |
| 2073 | 1.7.1.2.11.8 | CCAG recommend final code to PSG for baselining | milestone | 0d | 2024-08-21 A | 2024-08-21 A | 2072 | 100% |  | 2024-08-21 | 2024-08-21 | 0d | 2024-08-23 | 2024-08-23 |  |  |  | PP | Code Drafting PM |  | 5.9 | Andrew Margan | Regulatory | Complete | COMPLETE | MHHS-ART060 | T3-RE-0550 | CCAG | T2 |
| 2074 | 1.7.1.3 | Code changes baselined (M6) | milestone | 0d | 2024-08-23 A | 2024-08-23 A | 2072FS+2d, 2064, 2051, 2039, 2030, 2021, 2012, 2003, 1994, 1985 | 100% |  | 2024-08-23 | 2024-08-23 | 0d | 2024-08-23 | 2024-08-23 |  |  |  | CPT | PP |  | 5.0 | Andrew Margan | Regulatory | Complete | COMPLETE | MHHS-ART012 | T1-RE-1000 | PSG | T1 |
| 2075 | 1.7.2 | **Ofgem preparation and enactment of SCR powers** |  | 225d | 2024-02-05 A | 2024-12-13 |  | 71% | 65.25d | 2024-02-05 | 2024-12-13 | 225d | 2024-01-26 | 2024-11-12 | 789d |  | -0 | N/A | N/A | M7 | 5.0 | N/A | Regulatory |  |  |  |  |  |  |
| 2076 | 1.7.2.1 | **Preparation and enactment of SCR Powers** |  | 223d | 2024-02-05 A | 2024-12-11 |  | 72% | 63.28d | 2024-02-05 | 2024-12-11 | 223d | 2024-01-26 | 2024-11-11 | 726d |  | -0 | N/A | N/A |  | 5.0 | N/A | Regulatory |  |  |  |  |  |  |
| 2077 | 1.7.2.1.1 | Ofgem to keep Ofgem legal informed of process followed and nature of Code drafting to ensure that prepared for SCR go/no go decision |  | 101d | 2024-02-05 A | 2024-06-24 A | 2078SF | 100% |  | 2024-02-05 | 2024-06-24 | 101d | 2024-01-26 | 2024-06-14 |  |  |  | Ofgem | Code Bodies |  | 5.0 | Andrew Margan | Regulatory | Complete | COMPLETE |  |  |  |  |
| 2078 | 1.7.2.1.2 | OFGEM Legal to review Code Artefacts deliver policy intent and process followed and confirm that SCR powers are appropriate to use rather than SMAP - SCR go/no go |  | 14d | 2024-06-24 A | 2024-07-11 A | 2069SS | 100% |  | 2024-06-24 | 2024-07-11 | 15d | 2024-06-14 | 2024-07-04 |  |  |  | Ofgem | Code Bodies |  | 5.0 | Andrew Margan | Regulatory | Complete | COMPLETE |  |  |  |  |
| 2079 | 1.7.2.1.3 | Code Bodies to draft MOD proposal forms |  | 20d | 2024-07-12 A | 2024-08-08 A | 2078 | 100% |  | 2024-07-12 | 2024-08-08 | 20d | 2024-07-05 | 2024-08-01 |  |  |  | Code Bodies | Ofgem |  | 5.0 | Andrew Margan | Regulatory | Complete | COMPLETE |  |  |  |  |
| 2080 | 1.7.2.1.4 | Ofgem discuss and agree code mod timetable with code bodies (and MHHSP in relation to the dates for expected decisions) |  | 20d | 2024-07-12 A | 2024-08-08 A | 2078 | 100% |  | 2024-07-12 | 2024-08-08 | 20d | 2024-07-05 | 2024-08-01 |  |  |  | Ofgem | Code Bodies |  | 5.0 | Andrew Margan | Regulatory | Complete | COMPLETE |  |  |  |  |
| 2081 | 1.7.2.1.5 | Ofgem to publish each Direction to each code body specifying the timetable for each modification |  | 1d | 2024-08-28 A | 2024-08-28 A | 2080FS+13d | 100% |  | 2024-08-28 | 2024-08-28 | 1d | 2024-08-28 | 2024-08-28 |  |  |  | Ofgem | Code Bodies |  | 5.0 | Andrew Margan | Regulatory | Complete | COMPLETE |  |  |  |  |
| 2082 | 1.7.2.1.6 | Formally submit (by separate email) Modification Proposal Forms and legal texts to each code body |  | 1d | 2024-08-28 A | 2024-08-28 A | 2080FS+13d | 100% |  | 2024-08-28 | 2024-08-28 | 1d | 2024-08-28 | 2024-08-28 |  |  |  | Ofgem | Code Bodies |  | 5.0 | Andrew Margan | Regulatory | Complete | COMPLETE |  |  |  |  |
| 2083 | 1.7.2.1.7 | Each Code Body publishes and issues Modification Proposal Forms |  | 3d | 2024-08-29 A | 2024-09-02 A | 2082, 2081 | 100% |  | 2024-08-29 | 2024-09-02 | 3d | 2024-08-29 | 2024-09-02 |  |  |  | Code Bodies | Ofgem |  | 5.0 | Andrew Margan | Regulatory | Complete | COMPLETE |  |  |  |  |
| 2084 | 1.7.2.1.8 | Each Code Body sends Modification Proposal Forms to Panel to approve Mod to go to consultation |  | 10d | 2024-09-03 A | 2024-09-16 | 2083 | 33% | 6.7d | 2024-09-03 | 2024-09-16 | 10d | 2024-09-03 | 2024-09-16 | 726d | 0d |  | Code Bodies | Ofgem |  | 5.0 | Andrew Margan | Regulatory | Green | AMBER |  |  |  |  |
| 2085 | 1.7.2.1.9 | Modification Proposal approved by Panel for Consultation |  | 1d | 2024-09-17 | 2024-09-17 | 2084 |  |  | 2024-09-17 | 2024-09-17 | 1d | 2024-09-17 | 2024-09-17 | 726d | 0d |  | Code Bodies | Ofgem | -30.67 | 5.0 | Andrew Margan | Regulatory | Green | AMBER |  |  |  |  |
| 2086 | 1.7.2.1.10 | Draft Modification Report issued for consultation |  | 1d | 2024-09-18 | 2024-09-18 | 2085 |  |  | 2024-09-18 | 2024-09-18 | 1d | 2024-09-18 | 2024-09-18 | 726d | 0d |  | Code Bodies | Ofgem | -29.67 | 5.0 | Andrew Margan | Regulatory | Green | AMBER |  |  |  |  |
| 2087 | 1.7.2.1.11 | Consultation Close-out for representations |  | 15d | 2024-09-19 | 2024-10-09 | 2086 |  |  | 2024-09-19 | 2024-10-09 | 15d | 2024-09-19 | 2024-10-09 | 726d | 0d |  | Code Bodies | Ofgem | -28.67 | 5.0 | Andrew Margan | Regulatory | Green | GREEN |  |  |  |  |
| 2088 | 1.7.2.1.12 | Each Code Body reviews consultation response and drafts Modification Report |  | 10d | 2024-10-10 | 2024-10-23 | 2087 |  |  | 2024-10-10 | 2024-10-23 | 10d | 2024-10-10 | 2024-10-23 | 726d | 0d |  | Code Bodies | Ofgem | -7.67 | 5.0 | Andrew Margan | Regulatory | Green | GREEN |  |  |  |  |
| 2089 | 1.7.2.1.13 | Final Modification Report sent to Panel for decision with recommendation to approve |  | 1d | 2024-10-24 | 2024-10-24 | 2088 |  |  | 2024-10-24 | 2024-10-24 | 1d | 2024-10-24 | 2024-10-24 | 726d | 0d |  | Code Bodies | Ofgem | 6.33 | 5.0 | Andrew Margan | Regulatory | Green | GREEN |  |  |  |  |
| 2090 | 1.7.2.1.14 | Modification Panel decision |  | 1d | 2024-11-07 | 2024-11-07 | 2089FS+9d |  |  | 2024-11-07 | 2024-11-07 | 1d | 2024-11-07 | 2024-11-07 | 726d | 0d |  | Code Bodies | Ofgem | 20.33 | 5.0 | Andrew Margan | Regulatory | Green | GREEN |  |  |  |  |
| 2091 | 1.7.2.1.15 | Code Bodies Submit Final Modification/Change Reports |  | 1d | 2024-11-08 | 2024-11-08 | 2090 |  |  | 2024-11-08 | 2024-11-08 | 1d |  |  | 726d | 0d |  | Code Bodies | Ofgem | 21.33 | 5.31 | Andrew Margan |  | Green | GREEN |  |  |  |  |
| 2092 | 1.7.2.1.16 | Ofgem Reviews Final Modification/Change Reports |  | 10d | 2024-11-11 | 2024-11-22 | 2091 |  |  | 2024-11-11 | 2024-11-22 | 10d |  |  | 726d | 0d |  | Ofgem | Code Bodies | 24.33 | 5.31 | Andrew Margan |  | Green | GREEN |  |  |  |  |
| 2093 | 1.7.2.1.17 | Ofgem Drafts Decision/Direction Letters |  | 17d | 2024-11-18 | 2024-12-10 | 2092SS+5d |  |  | 2024-11-18 | 2024-12-10 | 17d |  |  | 726d | 0d |  | Ofgem | Code Bodies | 31.33 | 5.31 | Andrew Margan |  | Green | GREEN |  |  |  |  |
| 2094 | 1.7.2.1.18 | Ofgem Internally Signs Off the Decision/Direction Letters and Sends Them to the Code Bodies |  | 1d | 2024-12-11 | 2024-12-11 | 2093 |  |  | 2024-12-11 | 2024-12-11 | 1d |  |  | 726d | 0d |  | Ofgem | Code Bodies | 54.33 | 5.31 | Andrew Margan |  | Green | GREEN |  |  |  |  |
| 2095 | 1.7.2.2 | Ofgem decisions on M6 baselined code modification proposals (M7) | milestone | 0d | 2024-12-11 | 2024-12-11 | 2074, 2094 |  |  | 2024-12-11 | 2024-12-11 | 0d | 2024-11-11 | 2024-11-11 | 726d | 0d |  | CPT | PP | 54.71 | 5.31 | Andrew Margan | Regulatory | Green | GREEN | MHHS-ART012 | T2-RE-0600 | CCAG | T2 |
| 2096 | 1.7.2.3 | Ofgem Publishes the Decisions/Directions |  | 2d | 2024-12-12 | 2024-12-13 | 2095 |  |  | 2024-12-12 | 2024-12-13 | 2d |  |  | 789d |  |  | Ofgem | Code Bodies | 55.33 | 5.31 | Andrew Margan |  | Green | GREEN |  |  |  |  |

Notes:
- 2064: 10/10 - CH - Agreed at PSG on 4/10 to downgrade from T2 to T3
- 2073: 10/10 - CH - Agreed at PSG on 4/10 to downgrade from T2 to T3
- 2074: CCAG will approve the code text to go to Ofgem on 23/8/24. PSG will then ratify the milestone at PSG on 2/9/24
- 2084: 16/09/24 - Modifications sent to Panel. Individual CB meeting cycle not aligned to the plan, but no concerns or delays expected to Consultation Close-out (6460).
- 2085: 16/09/24 - Modifications sent to Panel. Individual CB meeting cycle not aligned to the plan, but no concerns or delays expected to Consultation Close-out (6460).
- 2086: 16/09/24 - Modifications sent to Panel. Individual CB meeting cycle not aligned to the plan, but no concerns or delays expected to Consultation Close-out (6460).
- 2095: Guidance: 5/8/25 - CR no52 and going to PSG on 7/8/24. 21/8/24: Milestone name and date change approved at psg on 7/8/24

| ID | WBS | Task | Type | Duration | Start | Finish | Predecessors | Complete | Remaining | Baseline start | Baseline finish | Baseline duration | Baseline 1 start | Baseline 1 finish | Total slack | Free slack | Constraint | Baseline cost | Responsible | Involved | Task Status | Update Version | MHHS Resource Name | MHHS Programme Phase | Sched Status | RAG | Artefact ID | Milestone ID | Text29 | Tier | Text3 |
| --- | --- | --- | --- | --- | --- | --- | --- | --- | --- | --- | --- | --- | --- | --- | --- | --- | --- | --- | --- | --- | --- | --- | --- | --- | --- | --- | --- | --- | --- | --- | --- |
| 2097 | 1.7.3 | **Deliver MHHS Code Changes** |  | 292d | 2024-11-12 | 2025-12-24 |  |  |  | 2024-11-12 | 2025-12-24 | 149d | 2024-11-12 | 2025-03-07 | 521d |  |  |  | N/A | N/A | M8 | 5.0 | N/A | Regulatory |  |  |  |  |  |  |  |
| 2098 | 1.7.3.1 | **Releases** |  | 292d | 2024-11-12 | 2025-12-24 |  |  |  | 2024-11-12 | 2025-12-24 | 149d | 2024-11-12 | 2025-03-07 | 521d |  |  |  | N/A | N/A |  | 5.0 | N/A | Regulatory |  |  |  |  |  |  |  |
| 2099 | 1.7.3.1.1 | Impacted codes make resourcing provisions and prepare to implement new Code via internal code body change processes |  | 78d | 2024-11-12 | 2025-02-27 |  |  |  | 2024-11-12 | 2025-02-27 | 78d | 2024-11-12 | 2025-02-27 | 735d |  | start no earlier than 2024-11-12 |  | Code Bodies |  | 25.33 | 5.0 | Andrew Margan | Regulatory | Green | GREEN |  |  |  |  |  |
| 2100 | 1.7.3.1.2 | **Main Code Release** |  | 71d | 2025-09-17 | 2025-12-24 |  |  |  | 2025-09-17 | 2025-12-24 | 71d | 2025-02-28 | 2025-03-07 | 521d |  |  |  | N/A | N/A |  | 5.0 | N/A | Regulatory |  |  |  |  |  |  |  |
| 2101 | 1.7.3.1.2.1 | Release preparation (e.g. preparing release documentation) |  | 6d | 2025-09-17 | 2025-09-24 | 2102SF |  |  | 2025-09-17 | 2025-09-24 | 5d | 2025-02-28 | 2025-03-07 | 586d |  |  |  | Code Bodies |  | 334.33 | 5.0 | Andrew Margan | Regulatory | Green | GREEN |  |  |  |  |  |
| 2102 | 1.7.3.1.2.2 | Implement new code on day of code release | milestone | 0d | 2025-09-24 | 2025-09-24 | 2103SF |  |  | 2025-09-24 | 2025-09-24 | 1d | 2025-03-07 | 2025-03-07 | 586d | 0d |  |  | Code Bodies |  | 341.71 | 5.0 | Andrew Margan | Regulatory | Green | GREEN |  |  |  |  |  |
| 2103 | 1.7.3.1.2.3 | Code changes delivered (M8) | milestone | 0d | 2025-09-24 | 2025-09-24 | 2095, 2074, 1493SS |  |  | 2025-09-24 | 2025-09-24 | 0d | 2025-03-07 | 2025-03-07 | 521d | 0d |  |  | CPT | Code Bodies,PP | 341.71 | 5.0 | Andrew Margan | Regulatory | Green | GREEN | MHHS-ART060 | T2-RE-0650 | CCAG | T2 |  |
| 2104 | 1.7.3.1.2.4 | Code changes delivered (M8*) late exit | milestone | 0d | 2025-12-24 | 2025-12-24 | 2103FS+65d |  |  | 2025-12-24 | 2025-12-24 | 0d |  |  | 521d |  |  |  | CPT | Code Bodies,PP | 432.71 | 5.1 | Andrew Margan | Regulatory | Green | GREEN | MHHS-ART060 | T2-RE-0700 | CCAG | T2 |  |
| 2105 | 1.7.4 | **External Programme Dependency Management** |  | 38d | 2023-12-01 A | 2024-01-24 A |  | 100% |  | 2023-12-01 | 2024-01-24 | 38d | 2023-09-08 | 2024-01-24 |  |  |  |  | N/A | N/A |  | 5.0 | N/A | Regulatory |  |  |  |  |  |  |  |
| 2106 | 1.7.4.1 | **DCP397** |  | 38d | 2023-12-01 A | 2024-01-24 A |  | 100% |  | 2023-12-01 | 2024-01-24 | 38d | 2023-09-08 | 2024-01-24 |  |  |  |  | N/A | N/A |  | 5.0 | N/A | Regulatory |  |  |  |  |  |  |  |
| 2107 | 1.7.4.1.1 | Ensure DCP397 drafting included in mop-up code drafting activity (link to mop-up) |  | 20d | 2023-12-01 A | 2023-12-28 A | 2058SS, 2055SS | 100% |  | 2023-12-01 | 2023-12-28 | 20d | 2023-09-08 | 2023-10-05 |  |  |  |  | CPT | Code Bodies,SRO Design, Code Drafting PM |  | 5.0 | Andrew Margan | Regulatory | Complete | COMPLETE |  |  |  |  |  |
| 2108 | 1.7.4.1.2 | Implementation of DCP397 | milestone | 0d | 2024-01-24 A | 2024-01-24 A |  | 100% |  | 2024-01-24 | 2024-01-24 | 0d | 2024-01-24 | 2024-01-24 |  |  | start no earlier than 2024-01-24 |  | Code Bodies |  |  | 5.0 | Andrew Margan | Regulatory | Complete | COMPLETE |  |  |  |  |  |
| 2109 | 1.8 | **MIGRATION** |  | 1246d | 2022-10-31 A | 2027-08-09 |  | 35% | 806.59d | 2022-10-31 | 2027-08-09 | 1092d | 2022-10-31 | 2027-01-05 | 98d |  |  | -0 | N/A | N/A |  |  | N/A | Migration |  |  |  |  |  |  | 1 Oct 2024 - 31 Oct 2025 |
| 2110 | 1.8.1 | Migration Period Plan Review 1 Completed | milestone, inactive | 0d | 2025-01-31 | 2025-01-31 |  |  |  | 2025-01-31 | 2025-01-31 | 0d | 2025-01-31 | 2025-01-31 | 754d |  | finish no earlier than 2025-01-31 |  | SRO | PP,IPA | 105.71 | 5.28 | Simon chidwick | Migration |  | GREEN |  | T3-MI-0016 | MCAG (Migration) | T3 |  |
| 2111 | 1.8.2 | **Regulatory Governance** |  | 198d | 2024-04-01 A | 2025-01-01 |  | 47% | 105d | 2024-04-01 | 2025-01-01 | 173d |  |  | 776d |  |  | -0 | N/A | N/A |  | 5.28 | N/A |  |  |  |  |  |  |  |  |
| 2112 | 1.8.2.1 | Incentive Mods Created |  | 110d | 2024-04-01 A | 2024-08-30 |  | 85% | 17d | 2024-04-01 | 2024-08-30 | 85d |  |  | 776d | 0d | start no earlier than 2024-04-01 |  | SRO Migration | SRO Migration,Code Bodies,PP |  | 5.28 | Simon chidwick |  | Green | GREEN |  |  |  |  |  |
| 2113 | 1.8.2.2 | Incentives Implemented |  | 88d | 2024-09-02 | 2025-01-01 | 2112 |  |  | 2024-09-02 | 2025-01-01 | 88d |  |  | 776d |  | start no earlier than 2024-07-02 |  | Code Bodies | Code Bodies,SRO Migration | -45.67 | 5.28 | Simon chidwick |  | Green | GREEN |  |  |  |  |  |
| 2114 | 1.8.3 | **Migration Framework Agreed and Implemented** |  | 256d | 2024-02-01 A | 2025-01-23 |  | 62% | 97.34d | 2024-02-01 | 2025-01-23 | 214d |  |  | 121d |  |  | -0 | N/A | N/A |  | 5.28 | N/A |  |  |  |  |  |  |  |  |
| 2115 | 1.8.3.1 | **Consultation 1 - Schedule** |  | 70d | 2024-02-01 A | 2024-05-08 A |  | 100% |  | 2024-02-01 | 2024-05-08 | 70d |  |  |  |  |  |  | N/A | N/A |  | 5.28 | N/A |  |  |  |  |  |  |  |  |
| 2116 | 1.8.3.1.1 | Prepare Artefacts for Consultation |  | 33d | 2024-02-01 A | 2024-03-18 A |  | 100% |  | 2024-02-01 | 2024-03-18 | 33d |  |  |  |  |  |  |  |  |  | 5.28 | Simon chidwick |  | Complete | COMPLETE |  |  |  |  |  |
| 2117 | 1.8.3.1.2 | Industry Consultation |  | 16d | 2024-03-18 A | 2024-04-08 A |  | 100% |  | 2024-03-18 | 2024-04-08 | 16d |  |  |  |  |  |  |  |  |  | 5.28 | Simon chidwick |  | Complete | COMPLETE |  |  |  |  |  |
| 2118 | 1.8.3.1.3 | Triage and Action Comments |  | 10d | 2024-04-08 A | 2024-04-19 A |  | 100% |  | 2024-04-08 | 2024-04-19 | 10d |  |  |  |  |  |  |  |  |  | 5.28 | Simon chidwick |  | Complete | COMPLETE |  |  |  |  |  |
| 2119 | 1.8.3.1.4 | Industry Assurance Review |  | 6d | 2024-04-19 A | 2024-04-26 A |  | 100% |  | 2024-04-19 | 2024-04-26 | 6d |  |  |  |  |  |  |  |  |  | 5.28 | Simon chidwick |  | Complete | COMPLETE |  |  |  |  |  |
| 2120 | 1.8.3.1.5 | MWG Recommendation |  | 1d | 2024-04-26 A | 2024-04-26 A |  | 100% |  | 2024-04-26 | 2024-04-26 | 1d |  |  |  |  |  |  |  |  |  | 5.28 | Simon chidwick |  | Complete | COMPLETE |  |  |  |  |  |
| 2121 | 1.8.3.1.6 | MCAG Interim Approval Artefacts |  | 1d | 2024-05-08 A | 2024-05-08 A |  | 100% |  | 2024-05-08 | 2024-05-08 | 1d |  |  |  |  |  |  |  |  |  | 5.28 | Simon chidwick |  | Complete | COMPLETE |  |  |  |  |  |

Notes:
- 2110: 2/7: To go to July MCAG for removal because milestone no longer reflects the delivery of the migration approach / Action: 11/7/24: MI-0016 warren is saying he wants another think about before going to MCAG so can you hold off doing anything official with that one please?

| ID | WBS | Task | Type | Duration | Start | Finish | Predecessors | Complete | Remaining | Baseline start | Baseline finish | Baseline duration | Total slack | Free slack | Baseline cost | Responsible | Involved | Update Version | MHHS Resource Name | Sched Status | RAG | Milestone ID | Text29 | Task Status |
| --- | --- | --- | --- | --- | --- | --- | --- | --- | --- | --- | --- | --- | --- | --- | --- | --- | --- | --- | --- | --- | --- | --- | --- | --- |
| 2122 | 1.8.3.2 | **Consultation 2 - Control** |  | 79d | 2024-04-08 A | 2024-07-25 A |  | 100% |  | 2024-04-08 | 2024-07-25 | 79d |  |  | -0 | N/A | N/A | 5.28 | N/A |  |  |  |  |  |
| 2123 | 1.8.3.2.1 | Prepare Artefacts for Consultation |  | 49d | 2024-04-08 A | 2024-06-13 A |  | 100% |  | 2024-04-08 | 2024-06-13 | 49d |  |  |  |  |  | 5.28 | Simon chidwick | Complete | COMPLETE |  |  |  |
| 2124 | 1.8.3.2.2 | Industry Consultation |  | 11d | 2024-06-14 A | 2024-06-28 A | 2123 | 100% |  | 2024-06-14 | 2024-06-28 | 11d |  |  |  |  |  | 5.28 | Simon chidwick | Complete | COMPLETE |  |  |  |
| 2125 | 1.8.3.2.3 | Triage and Action Comments |  | 9d | 2024-07-01 A | 2024-07-11 A | 2124 | 100% |  | 2024-07-01 | 2024-07-11 | 9d |  |  |  | SRO Migration | SRO Migration | 5.28 | Simon chidwick | Complete | COMPLETE |  |  |  |
| 2126 | 1.8.3.2.4 | Industry Assurance Review |  | 5d | 2024-07-12 A | 2024-07-18 A | 2125 | 100% |  | 2024-07-12 | 2024-07-18 | 5d |  |  |  | PP | PP,SRO Migration | 5.28 | Simon chidwick | Complete | COMPLETE |  |  |  |
| 2127 | 1.8.3.2.5 | MWG Recommendation | milestone | 0d | 2024-07-18 A | 2024-07-18 A | 2126 | 100% |  | 2024-07-18 | 2024-07-18 | 0d |  |  |  | PP | PP,SRO Migration | 5.28 | Simon chidwick | Complete | COMPLETE |  |  |  |
| 2128 | 1.8.3.2.6 | Consultation 2 - Control - MCAG Approval of Interim Artefacts | milestone | 0d | 2024-07-25 A | 2024-07-25 A | 2127FS+5d | 100% |  | 2024-07-25 | 2024-07-25 | 0d |  |  |  | PP | PP,SRO Migration | 5.30 | Simon chidwick | Complete | COMPLETE | T3-MI-0037 | MCAG (Migration) |  |
| 2129 | 1.8.3.3 | **Consultation 3 - Parameters** |  | 143d | 2024-07-09 A | 2025-01-23 |  | 18% | 117.21d | 2024-07-09 | 2025-01-23 | 76d | 121d |  | -0 | N/A | N/A | 5.28 | N/A |  |  |  |  |  |
| 2130 | 1.8.3.3.1 | Prepare Artefacts (9) for Consultation |  | 95d | 2024-07-09 A | 2024-11-18 | 2137SS+6d | 23% | 73d | 2024-07-09 | 2024-11-18 | 36d | 121d | 0d |  | SRO Migration | SRO Migration | 5.28 | Simon chidwick | Green | GREEN |  |  |  |
| 2131 | 1.8.3.3.2 | Industry Consultation |  | 10d | 2024-11-19 | 2024-12-02 | 2130 |  |  | 2024-11-19 | 2024-12-02 | 10d | 121d | 0d |  | PP | PP,SRO Migration | 5.28 | Simon chidwick | Green | GREEN |  |  | 32.33 |
| 2132 | 1.8.3.3.3 | Triage and Action Comments |  | 10d | 2024-12-03 | 2024-12-16 | 2131 |  |  | 2024-12-03 | 2024-12-16 | 10d | 121d | 0d |  | SRO Migration | SRO Migration | 5.28 | Simon chidwick | Green | GREEN |  |  | 46.33 |
| 2133 | 1.8.3.3.4 | Industry Assurance Review |  | 7d | 2024-12-17 | 2024-12-25 | 2132 |  |  | 2024-12-17 | 2024-12-25 | 7d | 121d | 0d |  | PP | PP,SRO Migration | 5.28 | Simon chidwick | Green | GREEN |  |  | 60.33 |
| 2134 | 1.8.3.3.5 | MWG Recommendation | milestone | 0d | 2025-01-06 | 2025-01-06 | 2133FS+8d |  |  | 2025-01-06 | 2025-01-06 | 0d | 121d | 0d |  | PP | PP,SRO Migration | 5.28 | Simon chidwick | Green | GREEN |  |  | 80.71 |
| 2135 | 1.8.3.3.6 | MCAG Approval of Migration Framework Artefacts (Baselined) | milestone | 0d | 2025-01-23 | 2025-01-23 | 2138, 2134FS+13d |  |  | 2025-01-23 | 2025-01-23 | 0d | 121d | 0d |  | PP | PP,SRO Migration | 5.30 | Simon chidwick | Green | RED | T3-MI-0017 | MCAG (Migration) | 97.71 |
| 2136 | 1.8.4 | **Migration Schedule Agreed and Maintained** |  | 415d | 2024-07-01 A | 2026-01-30 |  | 14% | 357.48d | 2024-07-01 | 2026-01-30 | 207d | 494d |  | -0 | N/A | N/A | 5.28 | N/A |  |  |  |  |  |
| 2137 | 1.8.4.1 | Indicative Envelopes Issued |  | 23d | 2024-07-01 A | 2024-07-31 A | 2121FS+37d | 100% |  | 2024-07-01 | 2024-07-31 | 23d |  |  |  | SRO Migration | SRO Migration,PP | 5.28 | Simon chidwick | Complete | COMPLETE |  |  |  |
| 2138 | 1.8.4.2 | Supplier Submissions |  | 45d | 2024-08-01 A | 2024-10-02 | 2137, 2128 | 11% | 40d | 2024-08-01 | 2024-10-02 | 45d | 202d | 0d |  | PP | SRO Migration,PP | 5.28 | Simon chidwick | Green | GREEN |  |  |  |
| 2139 | 1.8.4.3 | Team Assess Responses |  | 10d | 2024-10-03 | 2024-10-16 | 2138 |  |  | 2024-10-03 | 2024-10-16 | 10d | 552d | 0d |  | SRO Migration | SRO Migration | 5.28 | Simon chidwick | Green | GREEN |  |  | -14.67 |
| 2140 | 1.8.4.4 | Discuss and Agree Approach with Participants where necessary |  | 4d | 2024-10-17 | 2024-10-22 | 2139 |  |  | 2024-10-17 | 2024-10-22 | 4d | 552d | 58d |  | SRO Migration | SRO Migration,PP | 5.28 | Simon chidwick | Green | GREEN |  |  | -0.67 |
| 2141 | 1.8.4.5 | V1.0 of Migration Schedule Baseline Approved at MCAG | milestone | 0d | 2025-01-10 | 2025-01-10 | 2150, 2140 |  |  | 2025-01-10 | 2025-01-10 | 0d | 494d | 0d |  | PP | SRO Migration,PP | 5.30 | Simon chidwick | Green | GREEN | T3-MI-0039 | MCAG (Migration) | 84.71 |
| 2142 | 1.8.4.6 | Sprint Planning (Cycle 1) |  | 40d | 2025-06-16 | 2025-08-08 | 2141FS+110d |  |  | 2025-06-16 | 2025-08-08 | 20d | 494d | 0d |  | SRO Migration | SRO Migration,PP | 5.28 | Simon chidwick | Green | GREEN |  |  | 241.33 |
| 2143 | 1.8.4.7 | Sprint Planning (Cycle 2) |  | 40d | 2025-09-15 | 2025-11-07 | 2142FS+25d |  |  | 2025-09-15 | 2025-11-07 | 20d | 494d | 0d |  | SRO Migration | SRO Migration,PP | 5.28 | Simon chidwick | Green | GREEN |  |  | 332.33 |
| 2144 | 1.8.4.8 | Sprint Planning (Cycle 3) |  | 40d | 2025-12-08 | 2026-01-30 | 2143FS+20d, 2158 |  |  | 2025-12-08 | 2026-01-30 | 19d | 494d |  |  | SRO Migration | SRO Migration,PP | 5.28 | Simon chidwick | Green | GREEN |  |  | 416.33 |
| 2145 | 1.8.5 | **Migration Control Centre Tooling** |  | 242d | 2024-05-09 A | 2025-04-11 |  | 30% | 168.46d | 2024-05-09 | 2025-04-11 | 182d | 112d |  |  | N/A | N/A | 5.28 | N/A |  |  |  |  |  |
| 2146 | 1.8.5.1 | Data Source Definition |  | 120d | 2024-05-09 A | 2024-10-23 | 2121 | 46% | 65d | 2024-05-09 | 2024-10-23 | 60d | 112d | 0d |  | SRO Migration | SRO Migration | 5.28 | Simon chidwick | Green | GREEN |  |  |  |
| 2147 | 1.8.5.2 | Scheduling and Data Requirements |  | 120d | 2024-05-09 A | 2024-10-23 | 2121 | 46% | 65d | 2024-05-09 | 2024-10-23 | 60d | 112d | 0d |  | SRO Migration | SRO Migration | 5.28 | Simon chidwick | Green | GREEN |  |  |  |
| 2148 | 1.8.5.3 | Tool Phase 1 |  | 11d | 2024-10-24 | 2024-11-07 | 2147, 2146 |  |  | 2024-10-24 | 2024-11-07 | 11d | 112d | 0d |  | SRO Migration | SRO Migration | 5.28 | Simon chidwick | Green | GREEN |  |  | 6.33 |
| 2149 | 1.8.5.4 | Data Requirements |  | 21d | 2024-11-08 | 2024-12-06 | 2121, 2148 |  |  | 2024-11-08 | 2024-12-06 | 21d | 112d | 0d |  | SRO Migration | SRO Migration | 5.28 | Simon chidwick | Green | GREEN |  |  | 21.33 |
| 2150 | 1.8.5.5 | Tool Phase 2 |  | 25d | 2024-12-09 | 2025-01-10 | 2149 |  |  | 2024-12-09 | 2025-01-10 | 25d | 112d | 0d |  | SRO Migration | SRO Migration | 5.28 | Simon chidwick | Green | GREEN |  |  | 52.33 |
| 2151 | 1.8.5.6 | Data Source Provision |  | 7d | 2025-01-13 | 2025-01-21 | 2150 |  |  | 2025-01-13 | 2025-01-21 | 7d | 112d | 0d |  | SRO Migration | SRO Migration | 5.28 | Simon chidwick | Green | GREEN |  |  | 87.33 |
| 2152 | 1.8.5.7 | Tool - Internal and External Testing |  | 58d | 2025-01-22 | 2025-04-11 | 2151 |  |  | 2025-01-22 | 2025-04-11 | 58d | 112d | 0d |  | SRO Migration | SRO Migration,PP | 5.28 | Simon chidwick | Green | GREEN |  |  | 96.33 |

Notes:
- 2128: New milestone added to reflect updated delivery approach for migration. To go to July MCAG for approval / Guidance: 25/7/24: New Milestone approved at MCAG on 25/7/24
- 2135: Expected baseline date will change. This is due to a combination of the changes coming out of MWG for Consultation 3 being very minimal for the original release date of 28th August and not warranting an industry consultation, coupled with the reassessment of activity that has highlighted that it would be better to wait to align Consultation 3 with any changes that result from the current Supplier Migration Submission process, rather than issue a consultation before that process had completed and the MCC has digested the plans, and then have to issue yet further consultations. Current thinking is that the Consultation 3 would be issued in November and approved (and therefore the framework baselined) in December/January) / Guidance: 25/7/24: Milestone name and date change approved at MCAG on 25/7/24. Date from 2/8/24 to 22/10/24. Name from 'Migration Processes & Procedures approved' to 'MCAG Approval of Migration Framework Artefacts (Baselined)’
- 2141: On Track. / Guidance: 25/7/24: New Milestone approved at MCAG on 25/7/24
- 2144: Action: 8/7/24: Successor was on M10 (1861 id903) - I removed as it was moving the date out
- 2148: Action: 9/7/24: To be expanded once clarified
- 2149: Action: 9/7/24: To be expanded once clarified
- 2150: Action: 9/7/24: To be expanded once clarified
- 2151: Action: 9/7/24: To be expanded once clarified
- 2152: Action: 9/7/24: To be expanded once clarified

| ID | WBS | Task | Type | Duration | Start | Finish | Predecessors | Complete | Remaining | Baseline start | Baseline finish | Baseline duration | Baseline 1 start | Baseline 1 finish | Total slack | Free slack | Baseline cost | Responsible | Involved | Update Version | MHHS Resource Name | Sched Status | RAG | Task Status | MHHS Programme Phase | Artefact ID | Milestone ID | Text29 | Tier |
| --- | --- | --- | --- | --- | --- | --- | --- | --- | --- | --- | --- | --- | --- | --- | --- | --- | --- | --- | --- | --- | --- | --- | --- | --- | --- | --- | --- | --- | --- |
| 2153 | 1.8.6 | **Migration Control Centre Mobilised and Ready** |  | 185d | 2024-07-30 A | 2025-04-14 |  | 1% | 182.8d | 2024-07-30 | 2025-04-14 | 134d |  |  | 112d |  |  | N/A | N/A | 5.28 | N/A |  |  |  |  |  |  |  |  |
| 2154 | 1.8.6.1 | Migration Control Centre TOM Definition |  | 65d | 2024-07-30 A | 2024-10-28 | 2128FS+2d | 3% | 63d | 2024-07-30 | 2024-10-28 | 29d |  |  | 126d | 0d |  | SRO Migration | SRO Migration | 5.28 | Simon chidwick | Green | GREEN |  |  |  |  |  |  |
| 2155 | 1.8.6.2 | Access to Data |  | 25d | 2024-11-04 | 2024-12-06 | 2154FS+4d |  |  | 2024-11-04 | 2024-12-06 | 25d |  |  | 126d | 0d |  | SRO Migration | SRO Migration | 5.28 | Simon chidwick | Green | GREEN | 17.33 |  |  |  |  |  |
| 2156 | 1.8.6.3 | Migration Control Centre Delegation of Authority |  | 12d | 2024-12-24 | 2025-01-08 | 2155FS+11d |  |  | 2024-12-24 | 2025-01-08 | 12d |  |  | 126d | 0d |  | SRO Migration | SRO Migration | 5.28 | Simon chidwick | Green | GREEN | 67.33 |  |  |  |  |  |
| 2157 | 1.8.6.4 | Recruit and Train |  | 65d | 2024-12-24 | 2025-03-24 | 2156SS |  |  | 2024-12-24 | 2025-03-24 | 65d |  |  | 126d | 14d |  | SRO Migration | SRO Migration | 5.28 | Simon chidwick | Green | GREEN | 67.33 |  |  |  |  |  |
| 2158 | 1.8.6.5 | Dress Rehearsal |  | 1d | 2025-04-14 | 2025-04-14 | 2152, 2157, 2162, 2163 |  |  | 2025-04-14 | 2025-04-14 | 1d |  |  | 112d | 0d |  | SRO Migration | SRO Migration | 5.28 | Simon chidwick | Green | GREEN | 178.33 |  |  |  |  |  |
| 2159 | 1.8.7 | **PP's Prepared for Migration** |  | 196d | 2024-07-01 A | 2025-03-31 |  | 23% | 150.77d | 2024-07-01 | 2025-03-31 | 154d |  |  | 121d |  | -0 | N/A | N/A | 5.28 | N/A |  |  |  |  |  |  |  |  |
| 2160 | 1.8.7.1 | Prep for Envelope Webinar |  | 26d | 2024-07-01 A | 2024-08-05 A | 2137SS | 100% |  | 2024-07-01 | 2024-08-05 | 26d |  |  |  |  |  | SRO Migration | SRO Migration | 5.28 | Simon chidwick | Complete | COMPLETE |  |  |  |  |  |  |
| 2161 | 1.8.7.2 | Envelope/Submission Webinar |  | 1d | 2024-08-05 A | 2024-08-05 A | 2160FF | 100% |  | 2024-08-05 | 2024-08-05 | 1d |  |  |  |  |  | SRO Migration | SRO Migration,PP | 5.28 | Simon chidwick | Complete | COMPLETE |  |  |  |  |  |  |
| 2162 | 1.8.7.3 | Guides Creation |  | 45d | 2025-01-28 | 2025-03-31 | 2135FS+2d |  |  | 2025-01-28 | 2025-03-31 | 45d |  |  | 121d | 9d |  | SRO Migration | SRO Migration,PP | 5.28 | Simon chidwick | Green | GREEN | 102.33 |  |  |  |  |  |
| 2163 | 1.8.7.4 | Support Channels |  | 45d | 2025-01-28 | 2025-03-31 | 2135FS+2d |  |  | 2025-01-28 | 2025-03-31 | 45d |  |  | 121d | 9d |  | SRO Migration | SRO Migration,PP | 5.28 | Simon chidwick | Green | GREEN | 102.33 |  |  |  |  |  |
| 2164 | 1.8.8 | **Migration Artefact Development and Publication** |  | 743d | 2022-10-31 A | 2025-09-03 |  | 80% | 149.6d | 2022-10-31 | 2025-09-03 | 635d | 2022-10-31 | 2025-04-04 | 601d |  | -0 | N/A | N/A | 5.0 | N/A |  |  |  | Migration |  |  |  |  |
| 2165 | 1.8.8.1 | **Migration Approach** |  | 28d | 2022-10-31 A | 2022-12-07 A |  | 100% |  | 2022-10-31 | 2022-12-07 | 28d | 2022-10-31 | 2022-12-07 |  |  |  | N/A | N/A | 5.0 | N/A |  |  |  | Migration |  |  |  |  |
| 2166 | 1.8.8.1.1 | Option analysis (via MWG and PPIR) and recommendation |  | 23d | 2022-10-31 A | 2022-11-30 A |  | 100% |  | 2022-10-31 | 2022-11-30 | 23d | 2022-10-31 | 2022-11-30 |  |  |  | PP | SI Migration | 5.0 | John Wiggins,Matthew Breen | Complete | COMPLETE |  | Migration |  |  |  |  |
| 2167 | 1.8.8.1.2 | Migration Approach approved | milestone | 0d | 2022-12-07 A | 2022-12-07 A | 2166FS+5d | 100% |  | 2022-12-07 | 2022-12-07 | 0d | 2022-12-07 | 2022-12-07 |  |  |  | SI Migration | PP,IPA | 5.0 | John Wiggins,Matthew Breen | Complete | COMPLETE |  | Migration | MHHS-DEL770 | T3-MI-0010 | PSG | T3 |
| 2168 | 1.8.8.2 | **Migration Design** |  | 100d | 2022-11-14 A | 2023-03-31 A |  | 100% |  | 2022-11-14 | 2023-03-31 | 100d | 2022-11-14 | 2023-03-31 |  |  |  | N/A | N/A | 5.0 | N/A |  |  |  | Migration |  |  |  |  |
| 2169 | 1.8.8.2.1 | Review and update existing design artefacts and socialise with participants ahead of MDSG |  | 10d | 2022-11-14 A | 2022-11-25 A |  | 100% |  | 2022-11-14 | 2022-11-25 | 10d | 2022-11-14 | 2022-11-25 |  |  |  | SI Migration | SRO Design,CPT | 5.0 | John Wiggins,Matthew Breen | Complete | COMPLETE |  | Migration |  |  |  |  |
| 2170 | 1.8.8.2.2 | Develop design artefacts and supporting technical documents in line with MDSG |  | 53d | 2022-11-30 A | 2023-02-10 A | 2169FS+2d | 100% |  | 2022-11-30 | 2023-02-10 | 53d | 2022-11-30 | 2023-02-10 |  |  |  | SI Migration | PP,SRO Function,CPT | 5.0 | John Wiggins,Matthew Breen | Complete | COMPLETE |  | Migration |  |  |  |  |
| 2171 | 1.8.8.2.3 | Migration design artefacts issued for consultation | milestone | 0d | 2023-02-13 A | 2023-02-13 A | 2170FS+1d | 100% |  | 2023-02-13 | 2023-02-13 | 0d | 2023-02-13 | 2023-02-13 |  |  |  | SI Migration | PP,SRO Function,CPT | 5.0 | John Wiggins,Matthew Breen | Complete | COMPLETE |  | Migration |  | T3-MI-0011 | DAG | T3 |
| 2172 | 1.8.8.2.4 | Industry consultation |  | 5d | 2023-02-14 A | 2023-02-20 A | 2171SS | 100% |  | 2023-02-14 | 2023-02-20 | 5d | 2023-02-14 | 2023-02-20 |  |  |  | PP | SI Migration | 5.0 | John Wiggins,Matthew Breen | Complete | COMPLETE |  | Migration |  |  |  |  |
| 2173 | 1.8.8.2.5 | Review consultation feedback, address comments and update artefacts |  | 5d | 2023-02-21 A | 2023-02-27 A | 2172 | 100% |  | 2023-02-21 | 2023-02-27 | 5d | 2023-02-21 | 2023-02-27 |  |  |  | SI Migration | PP | 5.0 | John Wiggins,Matthew Breen | Complete | COMPLETE |  | Migration |  |  |  |  |
| 2174 | 1.8.8.2.6 | Internal artefact review and comms preparation |  | 3d | 2023-02-28 A | 2023-03-02 A | 2173 | 100% |  | 2023-02-28 | 2023-03-02 | 3d | 2023-02-28 | 2023-03-02 |  |  |  | SI Migration | SRO Function | 5.0 | John Wiggins,Matthew Breen | Complete | COMPLETE |  | Migration |  |  |  |  |
| 2175 | 1.8.8.2.7 | Updated Migration Design artefacts issued to PPs for assurance review | milestone | 0d | 2023-03-03 A | 2023-03-03 A | 2174FS+1d | 100% |  | 2023-03-03 | 2023-03-03 | 0d | 2023-03-03 | 2023-03-03 |  |  |  | SI Migration | PP | 5.0 | John Wiggins,Matthew Breen | Complete | COMPLETE |  | Migration |  | T3-MI-0013 | DAG | T3 |
| 2176 | 1.8.8.2.8 | Final Migration Design artefacts walkthrough with PPs | milestone | 0d | 2023-03-22 A | 2023-03-22 A | 2175FS+13d | 100% |  | 2023-03-22 | 2023-03-22 | 0d | 2023-03-22 | 2023-03-22 |  |  |  | SI Migration | PP | 5.0 | John Wiggins,Matthew Breen | Complete | COMPLETE |  | Migration |  |  |  |  |
| 2177 | 1.8.8.2.9 | Migration Design approved | milestone | 0d | 2023-03-31 A | 2023-03-31 A | 2176FS+7d | 100% |  | 2023-03-31 | 2023-03-31 | 0d | 2023-03-31 | 2023-03-31 |  |  |  | SI Migration | PP,SRO Function,CPT | 5.0 | John Wiggins,Matthew Breen | Complete | COMPLETE |  | Migration |  | T2-MI-0050 | DAG | T2 |

| ID | WBS | Task | Type | Duration | Start | Finish | Predecessors | Complete | Baseline start | Baseline finish | Baseline duration | Baseline 1 start | Baseline 1 finish | Baseline cost | Responsible | Involved | Update Version | MHHS Resource Name | MHHS Programme Phase | Sched Status | RAG | Milestone ID | Text29 | Tier | Guidance |
| --- | --- | --- | --- | --- | --- | --- | --- | --- | --- | --- | --- | --- | --- | --- | --- | --- | --- | --- | --- | --- | --- | --- | --- | --- | --- |
| 2178 | 1.8.8.3 | **Transition Design** |  | 186d | 2023-03-01 A | 2023-11-15 A |  | 100% | 2023-03-01 | 2023-11-15 | 186d | 2023-03-01 | 2023-08-03 | -0 | N/A | N/A | 5.0 | N/A | Migration |  |  |  |  |  |  |
| 2179 | 1.8.8.3.1 | **Tranche 1** |  | 56d | 2023-03-01 A | 2023-05-17 A |  | 100% | 2023-03-01 | 2023-05-17 | 56d | 2023-03-01 | 2023-05-17 |  | N/A | N/A | 5.0 | N/A | Migration |  |  |  |  |  |  |
| 2180 | 1.8.8.3.1.1 | Develop design artefacts and supporting technical details with participants |  | 50d | 2023-03-01 A | 2023-05-09 A |  | 100% | 2023-03-01 | 2023-05-09 | 50d | 2023-03-01 | 2023-05-09 |  | SI Design | PP | 5.0 | Andrew Margan | Migration | Complete | COMPLETE |  |  |  |  |
| 2181 | 1.8.8.3.1.2 | Issue Material for DAG approval |  | 1d | 2023-05-10 A | 2023-05-10 A | 2180 | 100% | 2023-05-10 | 2023-05-10 | 1d | 2023-05-10 | 2023-05-10 |  | PP | SI Design | 5.0 | Andrew Margan | Migration | Complete | COMPLETE |  |  |  |  |
| 2182 | 1.8.8.3.1.3 | Tranche 1 Transition Design approved | milestone | 0d | 2023-05-17 A | 2023-05-17 A | 2181FS+5d | 100% | 2023-05-17 | 2023-05-17 | 0d | 2023-05-17 | 2023-05-17 |  | SI Design | PP | 5.0 | Andrew Margan | Migration | Complete | COMPLETE | T2-DB-0150 | DAG | T2 |  |
| 2183 | 1.8.8.3.2 | **Tranche 2** |  | 130d | 2023-05-18 A | 2023-11-15 A |  | 100% | 2023-05-18 | 2023-11-15 | 130d | 2023-05-18 | 2023-08-03 | -0 | N/A | N/A | 5.0 | N/A | Migration |  |  |  |  |  |  |
| 2184 | 1.8.8.3.2.1 | Develop Initial design artefacts and supporting technical details |  | 76d | 2023-05-18 A | 2023-08-31 A | 2182 | 100% | 2023-05-18 | 2023-08-31 | 76d | 2023-05-18 | 2023-07-26 |  | SRO | PP, CPT, SRO Design | 5.5 | Andrew Margan | Migration | Complete | COMPLETE |  |  |  |  |
| 2185 | 1.8.8.3.2.2 | Communicate Initial Design Artefacts with Industry (MTDSG) |  | 1d | 2023-09-01 A | 2023-09-01 A | 2184 | 100% | 2023-09-01 | 2023-09-01 | 1d |  |  |  | SRO | PP, CPT, SRO Design | 5.5 | Andrew Margan | Migration | Complete | COMPLETE |  |  |  |  |
| 2186 | 1.8.8.3.2.3 | Host MTDSG |  | 1d | 2023-09-11 A | 2023-09-11 A | 2185FS+5d | 100% | 2023-09-11 | 2023-09-11 | 1d |  |  |  | SRO | PP, CPT, SRO Design | 5.5 | Andrew Margan | Migration | Complete | COMPLETE |  |  |  |  |
| 2187 | 1.8.8.3.2.4 | Process MTDSG Feedback and Amend Design Artefacts |  | 4d | 2023-09-12 A | 2023-09-15 A | 2186 | 100% | 2023-09-12 | 2023-09-15 | 4d |  |  |  | SRO | PP, CPT, SRO Design | 5.5 | Andrew Margan | Migration | Complete | COMPLETE |  |  |  |  |
| 2188 | 1.8.8.3.2.5 | Communicate Amended Design Artefacts with Industry |  | 1d | 2023-09-15 A | 2023-09-15 A | 2187FF | 100% | 2023-09-15 | 2023-09-15 | 1d |  |  |  | SRO | PP, CPT, SRO Design | 5.5 | Andrew Margan | Migration | Complete | COMPLETE |  |  |  |  |
| 2189 | 1.8.8.3.2.6 | Host MTDSG |  | 1d | 2023-09-26 A | 2023-09-26 A | 2188FS+6d | 100% | 2023-09-26 | 2023-09-26 | 1d |  |  |  | SRO | PP, CPT, SRO Design | 5.5 | Andrew Margan | Migration | Complete | COMPLETE |  |  |  |  |
| 2190 | 1.8.8.3.2.7 | Make Final Amendments to Design Artefact |  | 5d | 2023-09-27 A | 2023-10-03 A | 2189 | 100% | 2023-09-27 | 2023-10-03 | 5d |  |  |  | SRO | PP, CPT, SRO Design | 5.5 | Andrew Margan | Migration | Complete | COMPLETE |  |  |  |  |
| 2191 | 1.8.8.3.2.8 | Request DAG Consultation |  | 1d | 2023-10-04 A | 2023-10-04 A | 2190 | 100% | 2023-10-04 | 2023-10-04 | 1d |  |  |  | SRO | PP, CPT, SRO Design | 5.5 | Andrew Margan | Migration | Complete | COMPLETE |  |  |  |  |
| 2192 | 1.8.8.3.2.9 | Consultation Period |  | 11d | 2023-10-04 A | 2023-10-18 A | 2191SS | 100% | 2023-10-04 | 2023-10-18 | 11d |  |  |  | SRO | PP, CPT, SRO Design | 5.5 | Andrew Margan | Migration | Complete | COMPLETE |  |  |  |  |
| 2193 | 1.8.8.3.2.10 | Action Consultation Comments |  | 5d | 2023-10-19 A | 2023-10-25 A | 2192 | 100% | 2023-10-19 | 2023-10-25 | 5d |  |  |  | SRO | PP, CPT, SRO Design | 5.5 | Andrew Margan | Migration | Complete | COMPLETE |  |  |  |  |
| 2194 | 1.8.8.3.2.11 | Post Consultation Industry Assurance |  | 5d | 2023-10-26 A | 2023-11-01 A | 2193 | 100% | 2023-10-26 | 2023-11-01 | 5d |  |  |  | SRO | PP, CPT, SRO Design | 5.5 | Andrew Margan | Migration | Complete | COMPLETE |  |  |  |  |
| 2195 | 1.8.8.3.2.12 | Request DAG Approval |  | 1d | 2023-11-01 A | 2023-11-01 A | 2194FF | 100% | 2023-11-01 | 2023-11-01 | 1d |  |  |  | SRO | PP, CPT, SRO Design | 5.5 | Andrew Margan | Migration | Complete | COMPLETE |  |  |  |  |
| 2196 | 1.8.8.3.2.13 | DAG Transition Design Approved |  | 1d | 2023-11-08 A | 2023-11-08 A | 2195FS+4d | 100% | 2023-11-08 | 2023-11-08 | 1d |  |  |  | SRO | PP, CPT, SRO Design | 5.5 | Andrew Margan | Migration | Complete | COMPLETE |  |  |  |  |
| 2197 | 1.8.8.3.2.14 | Update Transition Design Admin |  | 5d | 2023-11-09 A | 2023-11-15 A | 2196 | 100% | 2023-11-09 | 2023-11-15 | 5d |  |  |  | SRO | PP, CPT, SRO Design | 5.5 | Andrew Margan | Migration | Complete | COMPLETE |  |  |  |  |
| 2198 | 1.8.8.3.2.15 | Tranche 2 Transition Design Baselined | milestone | 0d | 2023-11-15 A | 2023-11-15 A | 2197 | 100% | 2023-11-15 | 2023-11-15 | 0d | 2023-08-03 | 2023-08-03 |  | SRO | PP, CPT, SRO Design | 5.12 | Andrew Margan | Migration | Complete | COMPLETE | T2-DB-0250 | DAG | T2 | 14/8 - Date aligns with DAG |
| 2199 | 1.8.8.4 | **Data Assessment Report** |  | 61d | 2022-12-06 A | 2023-02-28 A |  | 100% | 2022-12-06 | 2023-02-28 | 61d | 2022-12-06 | 2023-02-28 |  | N/A | N/A | 5.0 | N/A | Migration |  |  |  |  |  |  |
| 2200 | 1.8.8.4.1 | Develop document with MWG |  | 49d | 2022-12-06 A | 2023-02-10 A |  | 100% | 2022-12-06 | 2023-02-10 | 49d | 2022-12-06 | 2023-02-10 |  | SI Migration |  | 5.0 | John Wiggins,Matthew Breen | Migration | Complete | COMPLETE |  |  |  |  |
| 2201 | 1.8.8.4.2 | Artefact review (via TMAG) and updates |  | 25d | 2023-01-18 A | 2023-02-21 A | 2200FS-18d | 100% | 2023-01-18 | 2023-02-21 | 25d | 2023-01-18 | 2023-02-21 |  | PP | IPA,SI Migration | 5.0 | John Wiggins,Matthew Breen | Migration | Complete | COMPLETE |  |  |  |  |
| 2202 | 1.8.8.4.3 | Data Assessment Report approved | milestone | 0d | 2023-02-28 A | 2023-02-28 A | 2201FS+5d | 100% | 2023-02-28 | 2023-02-28 | 0d | 2023-02-28 | 2023-02-28 |  | SI Migration | PP,IPA | 5.0 | John Wiggins,Matthew Breen | Migration | Complete | COMPLETE | T3-MI-0012 | MCAG | T3 |  |

Notes:
- 2198: 14/8 - Milestone aligned to 5 days after DAG approval, to update comms and admin on collaboration base. CR number to be added. 15/9 - Rebaseline approved at DAG on 13/9/23 / Action: 2/8/23 - needs to be replanned to 15//11/23. AM to raise CR as T2 milestone

| ID | WBS | Task | Type | Duration | Start | Finish | Predecessors | Complete | Remaining | Baseline start | Baseline finish | Baseline duration | Baseline 1 start | Baseline 1 finish | Total slack | Free slack | Constraint | Baseline cost | Responsible | Involved | Update Version | MHHS Resource Name | MHHS Programme Phase | Sched Status | RAG | Milestone ID | Text29 | Tier | Task Status | Guidance |
| --- | --- | --- | --- | --- | --- | --- | --- | --- | --- | --- | --- | --- | --- | --- | --- | --- | --- | --- | --- | --- | --- | --- | --- | --- | --- | --- | --- | --- | --- | --- |
| 2203 | 1.8.8.5 | **Migration, Cutover & Data Strategy (incl. Migration Entry Criteria)** |  | 102d | 2022-12-08 A | 2023-04-28 A |  | 100% |  | 2022-12-08 | 2023-04-28 | 102d | 2022-12-08 | 2023-04-28 |  |  |  |  | N/A | N/A | 5.0 | N/A | Migration |  |  |  |  |  |  |  |
| 2204 | 1.8.8.5.1 | Develop document with MWG |  | 67d | 2022-12-08 A | 2023-03-10 A | 2167 | 100% |  | 2022-12-08 | 2023-03-10 | 67d | 2022-12-08 | 2023-03-10 |  |  |  |  | SI Migration | PP | 5.0 | John Wiggins,Matthew Breen | Migration | Complete | COMPLETE |  |  |  |  |  |
| 2205 | 1.8.8.5.2 | Artefact review (via TMAG) and updates |  | 28d | 2023-03-15 A | 2023-04-21 A | 2204FS+2d | 100% |  | 2023-03-15 | 2023-04-21 | 28d | 2023-03-15 | 2023-04-21 |  |  |  |  | PP | SI Migration | 5.0 | John Wiggins,Matthew Breen | Migration | Complete | COMPLETE |  |  |  |  |  |
| 2206 | 1.8.8.5.3 | Migration, Cutover & Data Strategy approved | milestone | 0d | 2023-04-28 A | 2023-04-28 A | 2205FF+5d | 100% |  | 2023-04-28 | 2023-04-28 | 0d | 2023-04-28 | 2023-04-28 |  |  |  |  | SI Migration | PP | 5.0 | John Wiggins,Matthew Breen | Migration | Complete | COMPLETE | T3-MI-0014 | MCAG | T3 |  |  |
| 2207 | 1.8.8.6 | **Data Cleanse Plan** |  | 655d | 2023-03-02 A | 2025-09-03 |  | 65% | 227.78d | 2023-03-02 | 2025-09-03 | 547d | 2023-03-02 | 2025-04-04 | 601d |  |  | -0 | N/A | N/A | 5.0 | N/A | Migration |  |  |  |  |  |  |  |
| 2208 | 1.8.8.6.1 | Develop document with MWG |  | 50d | 2023-03-02 A | 2023-05-10 A |  | 100% |  | 2023-03-02 | 2023-05-10 | 50d | 2023-03-02 | 2023-05-10 |  |  |  |  | SI Migration | PP | 5.0 | John Wiggins,Matthew Breen | Migration | Complete | COMPLETE |  |  |  |  |  |
| 2209 | 1.8.8.6.2 | Artefact review (via TMAG) and updates |  | 20d | 2023-05-11 A | 2023-06-07 A | 2208 | 100% |  | 2023-05-11 | 2023-06-07 | 20d | 2023-05-11 | 2023-06-07 |  |  |  |  | PP | SI Migration,IPA | 5.0 | John Wiggins,Matthew Breen | Migration | Complete | COMPLETE |  |  |  |  |  |
| 2210 | 1.8.8.6.3 | Data Cleanse Plan approved | milestone | 0d | 2023-07-19 A | 2023-07-19 A | 2209FS+30d | 100% |  | 2023-07-19 | 2023-07-19 | 0d | 2023-06-14 | 2023-06-14 |  |  |  |  | SI Migration | PP | 5.0 | John Wiggins,Matthew Breen | Migration | Complete | COMPLETE | T3-MI-0020 | MCAG | T3 |  |  |
| 2211 | 1.8.8.6.4 | Monitor Programme Participant adherence to Data Cleanse Plan |  | 467d | 2023-06-15 A | 2025-03-28 | 2210 | 64% | 167d | 2023-06-15 | 2025-03-28 | 467d | 2023-06-15 | 2025-03-28 | 714d |  |  |  | SI Migration | PP | 5.0 | Matthew Breen | Migration | Green | GREEN |  |  |  |  |  |
| 2212 | 1.8.8.6.5 | **MTDs** |  | 120d | 2024-08-16 A | 2025-01-31 |  | 45% | 66d | 2024-08-16 | 2025-01-31 | 91d |  |  | 754d |  |  | -0 | N/A | N/A | 5.4 | N/A | Migration |  |  |  |  |  |  |  |
| 2213 | 1.8.8.6.5.1 | **ESME ID** |  | 90d | 2024-08-16 A | 2024-12-20 |  |  | 90d | 2024-08-16 | 2024-12-20 | 90d |  |  | 784d |  |  | -0 | N/A | N/A | 5.4 | N/A | Migration |  |  |  |  |  |  |  |
| 2214 | 1.8.8.6.5.1.1 | DCC to extract ESME ID and share with LDSO | milestone | 0d | 2024-08-16 A | 2024-08-16 A | 2210FS+282d | 100% |  | 2024-08-16 | 2024-08-16 | 0d |  |  |  |  |  |  | DCC/SI |  | 5.5 | Matthew Breen | Migration | Complete | COMPLETE | T3-MI-0024 | MCAG (Transition) | T3 |  |  |
| 2215 | 1.8.8.6.5.1.2 | LDSO ‘full refresh’ between their Registration Service and the EES (ESME ID) |  | 16d | 2024-10-21 | 2024-11-11 | 2214FS+45d |  |  | 2024-10-21 | 2024-11-11 | 0d |  |  | 784d | 0d |  |  | LDSO/EES |  | 5.5 | Matthew Breen | Migration | Green | GREEN | T3-MI-0025 | MCAG (Transition) | T3 | 3.33 |  |
| 2216 | 1.8.8.6.5.1.3 | Suppliers complete investigation of exceptions and resolution of exceptions |  | 1d | 2024-12-20 | 2024-12-20 | 2215FS+28d |  |  | 2024-12-20 | 2024-12-20 | 1d |  |  | 784d | 0d |  |  | Supplier |  | 5.4 | Matthew Breen | Migration | Green | GREEN |  |  |  | 63.33 |  |
| 2217 | 1.8.8.6.5.1.4 | ESME ID Complete | milestone | 0d | 2024-12-20 | 2024-12-20 | 2216 |  |  | 2024-12-20 | 2024-12-20 | 0d |  |  | 784d |  |  |  |  |  | 5.4 | Matthew Breen | Migration | Green | GREEN |  |  |  | 63.71 |  |
| 2218 | 1.8.8.6.5.2 | **Meter Location and Number of Displayed Register Digits** |  | 101d | 2024-09-13 A | 2025-01-31 |  | 78% | 21.96d | 2024-09-13 | 2025-01-31 | 91d |  |  | 754d |  |  |  | N/A | N/A | 5.4 | N/A | Migration |  |  |  |  |  |  |  |
| 2219 | 1.8.8.6.5.2.1 | MEM to extract data and share with LDSO |  | 6d | 2024-09-13 A | 2024-09-20 A | 2210FS+301d | 100% |  | 2024-09-13 | 2024-09-20 | 1d |  |  |  |  |  |  | MEM/SI |  | 5.4 | Matthew Breen | Migration | Complete | COMPLETE |  |  |  |  |  |
| 2220 | 1.8.8.6.5.2.2 | LDSO ‘full refresh’ between their Registration Service and the EES (Meter Location and Number of Displayed Register Digits) |  | 16d | 2024-10-28 A | 2024-11-18 | 2219FS+25d | 75% | 4d | 2024-10-28 | 2024-11-18 | 0d |  |  | 754d | 0d |  |  | LDSO /EES |  | 5.5 | Matthew Breen | Migration | Green | GREEN | T3-MI-0026 | MCAG (Transition) | T3 |  |  |
| 2221 | 1.8.8.6.5.2.3 | Suppliers complete investigation of exceptions and resolution of exceptions |  | 1d | 2025-01-31 | 2025-01-31 | 2220FS+53d |  |  | 2025-01-31 | 2025-01-31 | 1d |  |  | 754d | 0d |  |  | Supplier |  | 5.4 | Matthew Breen | Migration | Green | GREEN |  |  |  | 105.33 |  |
| 2222 | 1.8.8.6.5.2.4 | Meter Location and Number of Displayed Register Digits Complete | milestone | 0d | 2025-01-31 | 2025-01-31 | 2221 |  |  | 2025-01-31 | 2025-01-31 | 0d |  |  | 754d |  |  |  |  |  | 5.4 | Matthew Breen | Migration | Green | GREEN |  |  |  | 105.71 |  |
| 2223 | 1.8.8.6.6 | **Registration Data** |  | 259d | 2024-09-06 A | 2025-09-03 |  | 5% | 246.67d | 2024-09-06 | 2025-09-03 | 147d |  |  | 601d |  |  |  | N/A | N/A | 5.4 | N/A | Migration |  |  |  |  |  |  |  |
| 2224 | 1.8.8.6.6.1 | **Connection Type** |  | 47d | 2024-09-06 A | 2024-11-11 |  | 6% | 44.24d | 2024-09-06 | 2024-11-11 | 16d |  |  | 813d |  |  |  | N/A | N/A | 5.4 | N/A | Migration |  |  |  |  |  |  |  |
| 2225 | 1.8.8.6.6.1.1 | Automated Population of Connection Type for Measurement Classes ‘B’, ‘D’, ‘F’ & ‘G’ | milestone | 0d | 2024-10-04 A | 2024-10-04 A | 2210FS+317d | 100% |  | 2024-10-04 | 2024-10-04 | 0d |  |  |  |  | start no earlier than 2024-09-13 |  | LDSO |  | 5.5 | Matthew Breen | Migration | Complete | COMPLETE | T3-MI-0027 | MCAG (Transition) | T3 |  |  |
| 2226 | 1.8.8.6.6.1.2 | BAU Population of Connection Type for Site Specific LLFCs within Measurement Classes ‘C’ & ‘E’ | milestone | 0d | 2024-10-04 A | 2024-10-04 A | 2210FS+317d | 100% |  | 2024-10-04 | 2024-10-04 | 0d |  |  |  |  |  |  | LDSO |  | 5.5 | Matthew Breen | Migration | Complete | COMPLETE | T3-MI-0028 | MCAG (Transition) | T3 |  |  |
| 2227 | 1.8.8.6.6.1.3 | Automated Population of Connection Type for Smart Meters within Measurement Class ‘A’ | milestone | 0d | 2024-10-04 A | 2024-10-04 A | 2210FS+317d | 100% |  | 2024-10-04 | 2024-10-04 | 0d |  |  |  |  |  |  | LDSO |  | 5.5 | Matthew Breen | Migration | Complete | COMPLETE | T3-MI-0029 | MCAG (Transition) | T3 |  |  |
| 2228 | 1.8.8.6.6.1.4 | Population of Connection Type for Traditional and Advanced Meters within Measurement Class ‘A’ |  | 1d | 2024-09-06 A | 2024-09-06 A | 2210FS+296d | 100% |  | 2024-09-06 | 2024-09-06 | 1d |  |  |  |  |  |  | Suppliers |  | 5.4 | Matthew Breen | Migration | Complete | COMPLETE |  |  |  |  |  |
| 2229 | 1.8.8.6.6.1.5 | Automated Population of Null Connection Type | milestone | 0d | 2024-10-04 A | 2024-10-04 A | 2210FS+317d | 100% |  | 2024-10-04 | 2024-10-04 | 0d |  |  |  |  |  |  | LDSO |  | 5.5 | Matthew Breen | Migration | Complete | COMPLETE | T3-MI-0030 | MCAG (Transition) | T3 |  |  |
| 2230 | 1.8.8.6.6.1.6 | Full MPAN refresh to ESS |  | 16d | 2024-10-21 | 2024-11-11 | 2210FS+327d |  |  | 2024-10-21 | 2024-11-11 | 1d |  |  | 813d | 0d |  |  | LDSO/EES |  | 5.4 | Matthew Breen | Migration | Green | GREEN |  |  |  | 3.33 | Actually takes place on 29/9/24 which is a Sunday |
| 2231 | 1.8.8.6.6.1.7 | Connection Type Complete | milestone | 0d | 2024-11-11 | 2024-11-11 | 2225, 2226, 2227, 2228, 2229, 2230 |  |  | 2024-11-11 | 2024-11-11 | 0d |  |  | 813d |  |  |  |  |  | 5.4 | Matthew Breen | Migration | Green | GREEN |  |  |  | 24.71 |  |

Notes:
- 2212: 27/7 - CH added in with Matthew Breen
- 2213: 27/7 - CH added in with Matthew Breen
- 2214: 27/7 - CH added in with Matthew Breen
- 2215: 2/8/24: Date missed because Meter Location and Number of Displayed Register Digits has been delayed due to additional data validation activities. This will delay some of the data migration activities. To go to August MCAG for date change approval
- 2216: 27/7 - CH added in with Matthew Breen
- 2217: 27/7 - CH added in with Matthew Breen / Action: 2/8/24: is date right as different to baseline? Why was it 23rd?
- 2218: 27/7 - CH added in with Matthew Breen
- 2219: 27/7 - CH added in with Matthew Breen
- 2221: 27/7 - CH added in with Matthew Breen
- 2222: 27/7 - CH added in with Matthew Breen
- 2223: 27/7 - CH added in with Matthew Breen
- 2224: 27/7 - CH added in with Matthew Breen
- 2230: 27/7 - CH added in with Matthew Breen
- 2231: 27/7 - CH added in with Matthew Breen

| ID | WBS | Task | Type | Duration | Start | Finish | Predecessors | Complete | Remaining | Baseline start | Baseline finish | Baseline duration | Baseline 1 start | Baseline 1 finish | Total slack | Free slack | Constraint | Baseline cost | Responsible | Involved | Update Version | MHHS Resource Name | MHHS Programme Phase | Guidance | Task Status | Sched Status | RAG | Milestone ID | Text29 | Tier |
| --- | --- | --- | --- | --- | --- | --- | --- | --- | --- | --- | --- | --- | --- | --- | --- | --- | --- | --- | --- | --- | --- | --- | --- | --- | --- | --- | --- | --- | --- | --- |
| 2232 | 1.8.8.6.6.2 | **Domestic Premises Indicator** |  | 19d | 2025-08-08 | 2025-09-03 |  |  |  | 2025-08-08 | 2025-09-03 | 17d |  |  | 601d |  |  |  | N/A | N/A | 5.4 | N/A | Migration |  |  |  |  |  |  |  |
| 2233 | 1.8.8.6.6.2.1 | The DCC to extract Domestic Premises Indicator from the CSS and provide a file to each LDSO and EES. |  | 2d | 2025-08-08 | 2025-08-11 |  |  |  | 2025-08-08 | 2025-08-11 | 1d |  |  | 601d | 0d | start no earlier than 2025-08-08 |  | DCC |  | 5.4 | Matthew Breen | Migration | 27/7 - needs to end on date of M10 7/3/25 | 294.33 | Green | GREEN |  |  |  |
| 2234 | 1.8.8.6.6.2.2 | Each LDSO notifies the DCC of any exceptions |  | 1d | 2025-08-12 | 2025-08-12 | 2233 |  |  | 2025-08-12 | 2025-08-12 | 1d |  |  | 601d | 0d |  |  | LDSO |  | 5.4 | Matthew Breen | Migration | 27/7 - needs to end on date of M10 7/3/25 | 298.33 | Green | GREEN |  |  |  |
| 2235 | 1.8.8.6.6.2.3 | Each LDSO and DCC completes investigation and resolution of exceptions |  | 1d | 2025-09-03 | 2025-09-03 | 2233FS+15d, 2234FS+15d |  |  | 2025-09-03 | 2025-09-03 | 1d |  |  | 601d | 0d |  |  | LDSO / DCC |  | 5.4 | Matthew Breen | Migration | 27/7 Needs to take place approx. 1 month after M10 | 320.33 | Green | GREEN |  |  |  |
| 2236 | 1.8.8.6.6.2.4 | Domestic Premises Indicator Complete | milestone | 0d | 2025-09-03 | 2025-09-03 | 2235 |  |  | 2025-09-03 | 2025-09-03 | 0d |  |  | 601d |  |  |  |  |  | 5.4 | Matthew Breen | Migration |  | 320.71 | Green | GREEN |  |  |  |
| 2237 | 1.8.8.6.7 | **Export / Import MPANs** |  | 151d | 2024-03-22 A | 2024-10-18 |  | 99% | 0d | 2024-03-22 | 2024-10-18 | 151d |  |  | 829d |  |  |  | N/A | N/A | 5.4 | N/A | Migration |  |  |  |  |  |  |  |
| 2238 | 1.8.8.6.7.1 | **Linking of Export / Import MPANS** |  | 151d | 2024-03-22 A | 2024-10-18 |  | 99% | 0d | 2024-03-22 | 2024-10-18 | 151d |  |  | 829d |  |  |  | N/A | N/A | 5.4 | N/A | Migration |  |  |  |  |  |  |  |
| 2239 | 1.8.8.6.7.1.1 | LDSO utilises BAU processing (DB05s) to populate each import/export association |  | 1d | 2024-03-22 A | 2024-03-22 A | 2210FS+176d | 100% |  | 2024-03-22 | 2024-03-22 | 1d |  |  |  |  |  |  | LDSO |  | 5.4 | Matthew Breen | Migration |  |  | Complete | COMPLETE |  |  |  |
| 2240 | 1.8.8.6.7.1.2 | Each LDSO notifies the Registered Supplier of any exceptions |  | 1d | 2024-04-19 A | 2024-04-19 A | 2239FS+19d | 100% |  | 2024-04-19 | 2024-04-19 | 1d |  |  |  |  |  |  | LDSO |  | 5.4 | Matthew Breen | Migration |  |  | Complete | COMPLETE |  |  |  |
| 2241 | 1.8.8.6.7.1.3 | Each Supplier completes investigation and resolution of exceptions |  | 1d | 2024-08-23 A | 2024-08-23 A | 2240FS+89d | 100% |  | 2024-08-23 | 2024-08-23 | 1d |  |  |  |  |  |  | Supplier |  | 5.4 | Matthew Breen | Migration |  |  | Complete | COMPLETE |  |  |  |
| 2242 | 1.8.8.6.7.1.4 | Each LDSO has linked al relevant import/export MPANS | milestone | 0d | 2024-10-18 | 2024-10-18 | 2241FS+40d |  |  | 2024-10-18 | 2024-10-18 | 0d |  |  | 829d | 0d |  |  | LDSO |  | 5.5 | Matthew Breen | Migration |  | 0.71 | Green | GREEN | T3-MI-0031 | MCAG (Transition) | T3 |
| 2243 | 1.8.8.6.7.1.5 | Linking of Export / Import MPANS Complete | milestone | 0d | 2024-10-18 | 2024-10-18 | 2242 |  |  | 2024-10-18 | 2024-10-18 | 0d |  |  | 829d |  |  |  |  |  | 5.4 | Matthew Breen | Migration |  | 0.71 | Green | GREEN |  |  |  |
| 2244 | 1.8.8.6.8 | Pre-migration data cleanse complete | milestone | 0d | 2025-08-13 | 2025-08-13 |  |  |  | 2025-08-13 | 2025-08-13 | 0d | 2025-04-04 | 2025-04-04 | 617d |  | start no earlier than 2025-08-13 |  | SI Migration | PP | 5.0 | Matthew Breen | Migration |  | 299.33 | Green | GREEN | T2-MI-0450 | MCAG (Transition) | T2 |
| 2245 | 1.8.9 | **Migration Period Planning** |  | 367d | 2023-07-03 A | 2024-11-26 |  | 83% | 61.71d | 2023-07-03 | 2024-11-26 | 851d | 2023-07-03 | 2026-10-05 | 678d |  |  | -0 | N/A | N/A | 5.0 | N/A | Migration |  | M10 |  |  |  |  |  |
| 2246 | 1.8.9.1 | **Migration Implementation Plan (incl. Migration Exit Criteria)** |  | 367d | 2023-07-03 A | 2024-11-26 |  | 83% | 61.71d | 2023-07-03 | 2024-11-26 | 851d | 2023-07-03 | 2026-10-05 | 678d |  |  | -0 | N/A | N/A | 5.0 | N/A | Migration |  |  |  |  |  |  |  |
| 2247 | 1.8.9.1.1 | **Migration Threshold Volumes** |  | 101d | 2023-07-03 A | 2023-11-20 A |  | 100% |  | 2023-07-03 | 2023-11-20 | 98d | 2023-07-03 | 2023-08-31 |  |  |  | -0 | N/A | N/A | 5.0 | N/A | Migration |  |  |  |  |  |  |  |
| 2248 | 1.8.9.1.1.1 | Threshold volumes reviewed by MWG |  | 54d | 2023-07-03 A | 2023-09-14 A |  | 100% |  | 2023-07-03 | 2023-09-14 | 54d | 2023-07-03 | 2023-07-28 |  |  |  |  | SI Migration | PP | 5.6 | John Wiggins,Matthew Breen | Migration |  |  | Complete | COMPLETE |  |  |  |
| 2249 | 1.8.9.1.1.2 | Artefact review (via TMAG) and updates |  | 47d | 2023-09-15 A | 2023-11-20 A | 2248 | 100% |  | 2023-09-15 | 2023-11-20 | 44d | 2023-07-31 | 2023-08-31 |  |  |  |  | PP | SI Migration | 5.9 | John Wiggins,Matthew Breen | Migration |  |  | Complete | COMPLETE |  |  |  |
| 2250 | 1.8.9.1.1.3 | Threshold volumes approved at TMAG | milestone | 0d | 2023-11-20 A | 2023-11-20 A | 2249 | 100% |  | 2023-11-20 | 2023-11-20 | 0d | 2023-08-31 | 2023-08-31 |  |  |  |  | SI Migration | PP | 5.12 | John Wiggins,Matthew Breen | Migration |  |  | Complete | COMPLETE | T3-MI-0021 | SITAG | T3 |
| 2251 | 1.8.9.1.2 | **Define acceptance criteria for M15** |  | 78d | 2023-09-04 A | 2023-12-20 A |  | 100% |  | 2023-09-04 | 2023-12-20 | 78d | 2023-09-04 | 2023-11-30 |  |  |  | -0 | N/A | N/A | 5.0 | N/A | Migration |  |  |  |  |  |  |  |
| 2252 | 1.8.9.1.2.1 | Review acceptance criteria and reporting requirements with MWG |  | 49d | 2023-09-04 A | 2023-11-09 A |  | 100% |  | 2023-09-04 | 2023-11-09 | 40d | 2023-09-04 | 2023-10-27 |  |  | start no earlier than 2023-09-04 |  | SI Migration |  | 5.0 | John Wiggins,Matthew Breen | Migration |  |  | Complete | COMPLETE |  |  |  |
| 2253 | 1.8.9.1.2.2 | Artefact review (via TMAG) and updates |  | 29d | 2023-11-10 A | 2023-12-20 A | 2252 | 100% |  | 2023-11-10 | 2023-12-20 | 29d | 2023-10-30 | 2023-11-30 |  |  | start no earlier than 2023-10-30 |  | PP | SI Migration | 5.0 | John Wiggins,Matthew Breen | Migration |  |  | Complete | COMPLETE |  |  |  |
| 2254 | 1.8.9.1.2.3 | Acceptance criteria for M15 agreed at TMAG | milestone | 0d | 2023-12-20 A | 2023-12-20 A | 2253 | 100% |  | 2023-12-20 | 2023-12-20 | 0d | 2023-11-30 | 2023-11-30 |  |  | finish no earlier than 2023-11-30 |  | SI Migration |  | 5.14 | John Wiggins,Matthew Breen | Migration |  |  | Complete | COMPLETE | T3-MI-0022 | SITAG | T3 |
| 2255 | 1.8.9.1.3 | **M10/M11 cut-over plan** |  | 119d | 2023-12-21 A | 2024-06-04 A |  | 100% |  | 2023-12-21 | 2024-06-04 | 119d | 2024-01-01 | 2024-05-31 |  |  |  | -0 | N/A | N/A | 5.16 | N/A | Migration |  |  |  |  |  |  |  |
| 2256 | 1.8.9.1.3.1 | Draft Document |  | 84d | 2023-12-21 A | 2024-04-16 A | 2254 | 100% |  | 2023-12-21 | 2024-04-16 | 84d |  |  |  |  |  |  | SI Transition | SI Transition,PP,SRO | 5.16 | Matthew Breen | Migration |  |  | Complete | COMPLETE |  |  |  |
| 2257 | 1.8.9.1.3.2 | Share Document with SRO |  | 1d | 2024-04-17 A | 2024-04-17 A | 2256 | 100% |  | 2024-04-17 | 2024-04-17 | 1d |  |  |  |  |  |  | SI Transition | SI Transition,PP,SRO | 5.16 | Matthew Breen | Migration |  |  | Complete | COMPLETE |  |  |  |
| 2258 | 1.8.9.1.3.3 | Industry Consultation |  | 11d | 2024-04-23 A | 2024-05-07 A | 2257FS+3d | 100% |  | 2024-04-23 | 2024-05-07 | 11d |  |  |  |  |  |  | SI Transition | SI Transition,PP,SRO | 5.16 | Matthew Breen | Migration |  |  | Complete | COMPLETE |  |  |  |
| 2259 | 1.8.9.1.3.4 | Assurance Meeting |  | 1d | 2024-05-21 A | 2024-05-21 A | 2258FS+9d | 100% |  | 2024-05-21 | 2024-05-21 | 1d |  |  |  |  |  |  | SI Transition | SI Transition,PP,SRO | 5.16 | Matthew Breen | Migration |  |  | Complete | COMPLETE |  |  |  |
| 2260 | 1.8.9.1.3.5 | MCAG Approval of M10/M11 Cut-over Plan | milestone | 0d | 2024-06-04 A | 2024-06-04 A | 2259FS+10d | 100% |  | 2024-06-04 | 2024-06-04 | 0d | 2024-05-31 | 2024-05-31 |  |  |  |  | SI Transition | SI Transition,PP,SRO | 5.26 | Matthew Breen | Migration |  |  | Complete | COMPLETE | T3-MI-0023 | MCAG | T3 |

Notes:
- 2232: 27/7 - CH added in with Matthew Breen
- 2233: Baseline to be updated once CR55 recalibration is complete.
- 2234: Baseline to be updated once CR55 recalibration is complete.
- 2235: Baseline to be updated once CR55 recalibration is complete.
- 2236: Baseline to be updated once CR55 recalibration is complete.
- 2237: 27/7 - CH added in with Matthew Breen
- 2238: 27/7 - CH added in with Matthew Breen
- 2239: 27/7 - CH added in with Matthew Breen
- 2240: 27/7 - CH added in with Matthew Breen
- 2241: 27/7 - CH added in with Matthew Breen
- 2242: On track
- 2243: 27/7 - CH added in with Matthew Breen
- 2249: 7/11 - Red because date of TMAG chnaged
- 2250: Red as plan was to approve at extraordinary TMAG on 8/11, however regular TMAG taking place on 15/11 so deferred approval to this date. To go to TMAG for date change. Approved for date change at TMAG on 23/10/23. 7/11 - Red because date of TMAG changed
- 2254: 17/10 - Red because initial date was not aligned to a TMAG. On track to delivery by 20/12. To go to 20/11/23 TMAG for approval to change date. 20/11 - Date rebaselined. 20/12 - Approved at TMAG on 20/12
- 2260: 27/2 - Approved at MCAG on 27/2/24. 30/4: To go to 8th Red MCAG for rebaselining because MCAG is being rescheduled. 8/5 - Approved date change at MCAG on 8/5/24

| ID | WBS | Task | Type | Duration | Start | Finish | Predecessors | Complete | Remaining | Baseline start | Baseline finish | Baseline duration | Baseline 1 start | Baseline 1 finish | Total slack | Free slack | Constraint | Baseline cost | Responsible | Involved | Update Version | MHHS Resource Name | MHHS Programme Phase | Sched Status | RAG | Task Status | Milestone ID | Text29 | Tier | Action |
| --- | --- | --- | --- | --- | --- | --- | --- | --- | --- | --- | --- | --- | --- | --- | --- | --- | --- | --- | --- | --- | --- | --- | --- | --- | --- | --- | --- | --- | --- | --- |
| 2261 | 1.8.9.1.4 | **M16 Methodology** |  | 85d | 2024-07-31 A | 2024-11-26 |  | 10% | 76.9d | 2024-07-31 | 2024-11-26 | 85d | 2023-10-02 | 2024-04-26 | 678d |  |  | -0 | N/A | N/A | 5.0 | N/A | Migration |  |  |  |  |  |  |  |
| 2262 | 1.8.9.1.4.1 | Draft Document |  | 50d | 2024-07-31 A | 2024-10-08 |  | 12% | 44d | 2024-07-31 | 2024-10-08 | 50d | 2023-10-02 | 2023-12-29 | 678d | 0d |  |  | SI Transition | SI Transition,PP,SRO | 5.26 | Matthew Breen | Migration | Green | RED |  |  |  |  |  |
| 2263 | 1.8.9.1.4.2 | Share Document with SRO |  | 1d | 2024-10-09 | 2024-10-09 | 2262 |  |  | 2024-10-09 | 2024-10-09 | 1d | 2024-01-01 | 2024-01-26 | 678d | 0d |  |  | SI Transition | SI Transition,PP,SRO | 5.26 | Matthew Breen | Migration | Green | RED | -8.67 |  |  |  |  |
| 2264 | 1.8.9.1.4.3 | Industry Consultation |  | 11d | 2024-10-15 | 2024-10-29 | 2263FS+3d |  |  | 2024-10-15 | 2024-10-29 | 11d | 2024-01-29 | 2024-03-29 | 678d | 0d |  |  | SI Transition | SI Transition,PP,SRO | 5.26 | Matthew Breen | Migration | Green | RED | -2.67 |  |  |  |  |
| 2265 | 1.8.9.1.4.4 | Assurance Meeting |  | 1d | 2024-11-12 | 2024-11-12 | 2264FS+9d |  |  | 2024-11-12 | 2024-11-12 | 1d | 2024-04-01 | 2024-04-26 | 678d | 0d |  |  | SI Transition | SI Transition,PP,SRO | 5.26 | Matthew Breen | Migration | Green | RED | 25.33 |  |  |  |  |
| 2266 | 1.8.9.1.4.5 | M16 methodology approved | milestone | 0d | 2024-11-26 | 2024-11-26 | 2265FS+10d |  |  | 2024-11-26 | 2024-11-26 | 0d | 2024-04-26 | 2024-04-26 | 678d |  |  |  | SI Transition | SI Transition,PP,SRO | 5.26 | Matthew Breen | Migration | Green | RED | 39.71 | T3-MI-0500 | MCAG (Transition) | T2 |  |
| 2267 | 1.8.10 | **Preparation for Cutover to Live** |  | 344d | 2024-06-28 A | 2025-10-22 |  |  | 344d | 2024-06-28 | 2025-10-22 | 201d | 2025-02-07 | 2025-04-04 | 566d |  |  | -0 | N/A | N/A | 5.27 | N/A | Migration |  |  |  |  |  |  |  |
| 2268 | 1.8.10.1 | **Central Systems Prepare for Cutover to Live** |  | 326d | 2024-06-28 A | 2025-09-26 |  |  | 326d | 2024-06-28 | 2025-09-26 | 186d | 2025-02-07 | 2025-03-07 | 584d |  |  | -0 | N/A | N/A | 5.27 | N/A | Migration |  |  | M13 |  |  |  |  |
| 2269 | 1.8.10.1.1 | DCC (Functionality available June 2024) | milestone | 0d | 2024-06-28 A | 2024-06-28 A |  | 100% |  | 2024-06-28 | 2024-06-28 | 0d |  |  |  |  | start no earlier than 2024-06-28 |  | DCC |  | 5.27 | Matthew Breen |  | Complete | COMPLETE |  |  |  |  |  |
| 2270 | 1.8.10.1.2 | **Development of Comms Approach and Declaration Guidance** |  | 79d | 2025-03-03 | 2025-06-19 |  |  |  | 2025-03-03 | 2025-06-19 | 79d |  |  | 74d |  |  |  | N/A | N/A | 5.28 | N/A |  |  |  | 95.33 |  |  |  |  |
| 2271 | 1.8.10.1.2.1 | Draft Cutover Comms Approach |  | 59d | 2025-03-03 | 2025-05-22 |  |  |  | 2025-03-03 | 2025-05-22 | 59d |  |  | 74d | 0d | start no earlier than 2025-03-03 |  | SI Transition | SI Transition | 5.28 | Matthew Breen |  | Green | GREEN | 136.33 |  |  |  |  |
| 2272 | 1.8.10.1.2.2 | Draft Cutover Comms Approach shared | milestone | 0d | 2025-05-22 | 2025-05-22 | 2271 |  |  | 2025-05-22 | 2025-05-22 | 0d |  |  | 74d | 0d |  |  | SI Transition | SI Transition | 5.28 | Matthew Breen |  | Green | GREEN | 216.71 |  |  |  |  |
| 2273 | 1.8.10.1.2.3 | Development of Implementation Group |  | 59d | 2025-03-03 | 2025-05-22 |  |  |  | 2025-03-03 | 2025-05-22 | 59d |  |  | 74d | 0d | start no earlier than 2025-03-03 |  | SI Transition | SI Transition | 5.28 | Matthew Breen |  | Green | GREEN | 136.33 |  |  |  |  |
| 2274 | 1.8.10.1.2.4 | Implementation Group Established | milestone | 0d | 2025-05-22 | 2025-05-22 | 2273 |  |  | 2025-05-22 | 2025-05-22 | 0d |  |  | 74d | 0d |  |  | SI Transition | SI Transition | 5.28 | Matthew Breen |  | Green | GREEN | 216.71 |  |  |  |  |
| 2275 | 1.8.10.1.2.5 | Finalised Cutover Comms Approach shared | milestone | 0d | 2025-06-19 | 2025-06-19 | 2272FS+20d, 2274FS+20d |  |  | 2025-06-19 | 2025-06-19 | 0d |  |  | 74d | 69d |  |  | SI Transition | SI Transition | 5.28 | Matthew Breen |  | Green | GREEN | 244.71 |  |  |  |  |
| 2276 | 1.8.10.1.3 | **Development of Cutover Plan requirements with Participants** |  | 113d | 2025-03-03 | 2025-08-06 |  |  |  | 2025-03-03 | 2025-08-06 | 59d |  |  | 40d |  |  |  | N/A | N/A | 5.28 | N/A |  |  |  | -605.67 |  |  |  |  |
| 2277 | 1.8.10.1.3.1 | Development of SIT Participant Cutover Plans |  | 59d | 2025-03-03 | 2025-05-22 |  |  |  | 2025-03-03 | 2025-05-22 | 59d |  |  | 40d | 0d | start no earlier than 2025-03-03 |  | SI Transition | SI Transition | 5.28 | Matthew Breen |  | Green | GREEN | 136.33 |  |  |  |  |
| 2278 | 1.8.10.1.3.2 | SIT Participant Cutover Plans Ready | milestone | 0d | 2025-05-22 | 2025-05-22 | 2277 |  |  | 2025-05-22 | 2025-05-22 | 0d |  |  | 40d | 0d |  |  | SI Transition | SI Transition | 5.28 | Matthew Breen |  | Green | GREEN | 216.71 |  |  |  |  |
| 2279 | 1.8.10.1.3.3 | Programme SIT Participant Cutover Plan Assurance |  | 44d | 2025-06-06 | 2025-08-06 | 2278FS+10d |  |  | 2025-06-06 | 2025-08-06 | 44d |  |  | 40d | 35d |  |  | SI Transition | SI Transition | 5.28 | Matthew Breen |  | Green | GREEN | 231.33 |  |  |  |  |
| 2280 | 1.8.10.1.4 | **M10/M11 Cutover Activities** |  | 119d | 2025-04-14 | 2025-09-26 |  |  |  | 2025-04-14 | 2025-09-26 | 15d |  |  | 112d |  |  | -0 |  |  | 5.27 |  |  |  |  | -608.67 |  |  |  |  |
| 2281 | 1.8.10.1.4.1 | Production DIP Portal (DIP Deployment) | milestone | 0d | 2025-09-05 | 2025-09-05 | 1356FS+10d |  |  | 2025-09-05 | 2025-09-05 | 0d |  |  | 13d | 7d |  |  | Elexon,DIP Manager | Elexon,DIP Manager, SI Transition | 5.27 | Matthew Breen |  | Green | GREEN | 322.71 |  |  |  |  |
| 2282 | 1.8.10.1.4.2 | Production Certificates (DIP Deployment) | milestone | 0d | 2025-09-05 | 2025-09-05 | 1356FS+10d |  |  | 2025-09-05 | 2025-09-05 | 0d |  |  | 13d | 7d |  |  | Elexon,DIP Manager | Elexon,DIP Manager, SI Transition | 5.27 | Matthew Breen |  | Green | GREEN | 322.71 |  |  |  |  |
| 2283 | 1.8.10.1.4.3 | Completion of the pre-M10 MHHS Data Cleanse | milestone | 0d | 2025-09-24 | 2025-09-24 | 1493 |  |  | 2025-09-24 | 2025-09-24 | 0d |  |  | 586d |  |  |  | PP,DCC,SI Transition | PP,DCC,SI Transition | 5.27 | Matthew Breen |  | Green | GREEN | 341.71 |  |  |  |  |
| 2284 | 1.8.10.1.4.4 | Market-wide Participant MHHS Supporting Functionality Ready - Confirmation from Code Bodies | milestone | 0d | 2025-09-15 | 2025-09-15 | 1493FS-8d |  |  | 2025-09-15 | 2025-09-15 | 0d |  |  | 594d | 0d |  |  | Code Bodies | Code Bodies,SI Transition | 5.27 | Matthew Breen |  | Green | GREEN | 332.33 |  |  |  |  |
| 2285 | 1.8.10.1.4.5 | Market-wide Participant MHHS Supporting Functionality Ready | milestone | 0d | 2025-09-22 | 2025-09-22 | 1493FS-3d |  |  | 2025-09-22 | 2025-09-22 | 0d |  |  | 589d |  |  |  | PP | PP,SI Transition | 5.27 | Matthew Breen |  | Green | GREEN | 339.33 |  |  |  |  |
| 2286 | 1.8.10.1.4.6 | Elexon Central Services Deployment | milestone | 0d | 2025-09-19 | 2025-09-19 | 2308 |  |  | 2025-09-19 | 2025-09-19 | 0d |  |  | 5d | 0d |  |  | DIP Manager,Elexon | DIP Manager,Elexon,SI Transition | 5.27 | Matthew Breen |  | Green | GREEN | 336.71 |  |  |  |  |
| 2287 | 1.8.10.1.4.7 | Service Management Go-Live | milestone | 0d | 2025-09-19 | 2025-09-19 | 2308 |  |  | 2025-09-19 | 2025-09-19 | 0d |  |  | 5d | 0d |  |  | Elexon | Elexon,SI Transition | 5.27 | Matthew Breen |  | Green | GREEN | 336.71 |  |  |  |  |
| 2288 | 1.8.10.1.4.8 | Data Transfer Service (DTS) New Functionality Deployment | milestone | 0d | 2025-09-19 | 2025-09-19 | 2308 |  |  | 2025-09-19 | 2025-09-19 | 0d |  |  | 5d | 0d |  |  | Code Bodies,Electralink | Code Bodies,SI Transition | 5.27 | Matthew Breen |  | Green | GREEN | 336.71 |  |  |  |  |
| 2289 | 1.8.10.1.4.9 | Electricity Enquiry Service (EES) Deployment | milestone | 0d | 2025-09-19 | 2025-09-19 | 2308 |  |  | 2025-09-19 | 2025-09-19 | 0d |  |  | 5d | 0d |  |  | Code Bodies | Code Bodies,SI Transition | 5.27 | Matthew Breen |  | Green | GREEN | 336.71 |  |  |  |  |
| 2290 | 1.8.10.1.4.10 | MPRS, UMSO Role, LDSO Role Operational | milestone | 0d | 2025-09-19 | 2025-09-19 | 2308 |  |  | 2025-09-19 | 2025-09-19 | 0d |  |  | 5d | 0d |  |  | PP | SI Transition,PP | 5.27 | Matthew Breen |  | Green | GREEN | 336.71 |  |  |  |  |
| 2291 | 1.8.10.1.4.11 | Population of Domestic Premises Indicator | milestone | 0d | 2025-09-19 | 2025-09-19 | 2308 |  |  | 2025-09-19 | 2025-09-19 | 0d |  |  | 5d | 0d |  |  | PP,DCC,SI Transition | PP,DCC,SI Transition | 5.27 | Matthew Breen |  | Green | GREEN | 336.71 |  |  |  |  |
| 2292 | 1.8.10.1.4.12 | Population of Market Segment | milestone | 0d | 2025-09-19 | 2025-09-19 | 2308 |  |  | 2025-09-19 | 2025-09-19 | 0d |  |  | 5d | 0d |  |  | PP,SI Transition | PP,SI Transition | 5.27 | Matthew Breen |  | Green | GREEN | 336.71 |  |  |  |  |
| 2293 | 1.8.10.1.4.13 | Early Life Support Implemented | milestone | 0d | 2025-09-19 | 2025-09-19 | 2308 |  |  | 2025-09-19 | 2025-09-19 | 0d |  |  | 8d | 3d |  |  | SI Transition,Elexon,Central Services | SI Transition,Elexon,Central Services | 5.27 | Matthew Breen |  | Green | GREEN | 336.71 |  |  |  |  |
| 2294 | 1.8.10.1.4.14 | MCC Tested and Ready to Operate | milestone | 0d | 2025-04-14 | 2025-04-14 | 2158 |  |  | 2025-04-14 | 2025-04-14 | 0d |  |  | 112d | 0d |  |  | SI Migration | SI Migration | 5.27 | Matthew Breen |  | Green | GREEN | 178.71 |  |  |  | 1/7: To link into migration/service activation |
| 2295 | 1.8.10.1.4.15 | MCC Operational | milestone | 0d | 2025-04-14 | 2025-04-14 | 2294 |  |  | 2025-04-14 | 2025-04-14 | 0d |  |  | 122d | 117d |  |  | SI Migration | SI Migration | 5.27 | Matthew Breen |  | Green | GREEN | 178.71 |  |  |  | 1/7: To link into migration/service activation |
| 2296 | 1.8.4.1.4 | Central Systems live and Codes designated at 00:00 | milestone | 0d | 2025-09-22 | 2025-09-22 | 2286FS+1d, 2287FS+1d, 2288FS+1d, 2289FS+1d, 2290FS+1d, 2291FS+1d, 2292FS+1d, 2269FS+1d |  |  | 2025-09-22 | 2025-09-22 | 0d |  |  | 5d | 0d |  |  | SI Transition | SI Transition | 5.30 | Matthew Breen |  | Green | GREEN | 339.71 | T3-MI-0034 | MCAG (Transition) |  |  |
| 2297 | 1.8.10.1.4.17 | SIT Participant Qualification - The final date by which participant qualification status can be confirmed for participants to be ready for the start of Migration at M11. | milestone | 0d | 2025-09-26 | 2025-09-26 | 1356FS+25d |  |  | 2025-09-26 | 2025-09-26 | 0d |  |  | 16d | 11d |  |  | PP,Code Bodies,BSC PAB | SI Transition,PP,Code Bodies,BSC PAB | 5.27 | Matthew Breen |  | Green | GREEN | 343.71 |  |  |  |  |

Notes:
- 2266: Production of this artefact has been delayed pending discussion on outstanding artefacts to be produced through TORWG.
- 2284: 09/10/24 - WR and Fola O extended duration by 110d so the activity completes at 04/08/25.
- 2285: 09/10/24 - WR and Fola O reduced the lag so the activity completes at 11/08/25.
- 2296: 6/8/24: Forecast date updated to correctly reflect the cutover plan which was approved in June. To go to August MCAG for date change approval / Guidance: 25/7/24: New Milestone approved at MCAG on 25/7/24. It was initially approved at MCAG on 4/6 but didn't follow the usual process so addded to July MCAG for noting

| ID | WBS | Task | Type | Duration | Start | Finish | Predecessors | Baseline start | Baseline finish | Baseline duration | Total slack | Free slack | Constraint | Responsible | Involved | Task Status | Update Version | MHHS Resource Name | Sched Status | RAG | Milestone ID | Text29 |
| --- | --- | --- | --- | --- | --- | --- | --- | --- | --- | --- | --- | --- | --- | --- | --- | --- | --- | --- | --- | --- | --- | --- |
| 2298 | 1.8.10.2 | **Cutover Governance M10** |  | 41d | 2025-07-30 | 2025-09-24 |  | 2025-07-30 | 2025-09-24 | 27d | 39d |  |  | N/A | N/A | -595.67 | 5.27 | N/A |  |  |  |  |
| 2299 | 1.8.10.2.1 | Confirmation that Pre-migration Data Cleanse Activities have successfully taken place | milestone | 0d | 2025-07-30 | 2025-07-30 |  | 2025-07-30 | 2025-07-30 | 0d | 41d | 35d | start no earlier than 2025-07-30 | PP | SI Transition,PP | 285.33 | 5.27 | Matthew Breen | Green | GREEN |  |  |
| 2300 | 1.8.10.2.2 | Confirmation of Helix E2E Settlement Testing Complete | milestone | 0d | 2025-08-01 | 2025-08-01 | 1285FS+85d | 2025-08-01 | 2025-08-01 |  | 38d | 32d |  |  |  | 287.71 | 6.1 |  | Green | GREEN |  |  |
| 2301 | 1.8.10.2.3 | Confirmation of assurance of Helix E2E Settlement Testing | milestone | 0d | 2025-08-01 | 2025-08-01 | 1287FS+85d | 2025-08-01 | 2025-08-01 |  | 38d | 32d |  |  |  | 287.71 | 6.1 |  | Green | GREEN |  |  |
| 2302 | 1.8.10.2.4 | Confirmation of Qualification Status for SIT MVC | milestone | 0d | 2025-09-12 | 2025-09-12 | 1356FS+15d | 2025-09-12 | 2025-09-12 | 0d | 6d | 0d |  | SIT MVC,Code Bodies | SI Transition,SIT MVC,Code Bodies | 329.71 | 6.1 | Matthew Breen | Green | GREEN |  |  |
| 2303 | 1.8.10.2.5 | Confirmation of Qualification Status for Non-SIT LDSOs | milestone | 0d | 2025-09-15 | 2025-09-15 | 2308FS-5d | 2025-09-15 | 2025-09-15 | 0d | 594d |  |  | PP,Code Bodies | SI Transition,PP,Code Bodies | 332.33 | 5.27 | Matthew Breen | Green | GREEN |  |  |
| 2304 | 1.8.10.2.6 | Confirmation of Qualification Status of at least one Supplier and their contracted Agents | milestone | 0d | 2025-09-12 | 2025-09-12 | 2302 | 2025-09-12 | 2025-09-12 | 0d | 6d | 0d |  | S&A Qualification | SI Transition,S&A Qualification | 329.71 | 6.1 | Matthew Breen | Green | GREEN |  |  |
| 2305 | 1.8.10.2.7 | Declaration from all Central Services and LDSOs that they are in a position to move forwards | milestone | 0d | 2025-09-15 | 2025-09-15 | 2308FS-5d, 1285, 1287 | 2025-09-15 | 2025-09-15 | 0d | 594d |  |  | DIP Manager,Elexon,PP,Code Bodies | SI Transition,DIP Manager,Elexon,PP,Code Bodies | 332.33 | 5.27 | Matthew Breen | Green | GREEN |  |  |
| 2306 | 1.8.10.2.8 | Market-wide Participant MHHS Migration Supporting Functionality is Live | milestone | 0d | 2025-09-15 | 2025-09-15 | 2284 | 2025-09-15 | 2025-09-15 |  | 594d |  |  |  |  | 332.33 | 6.1 |  | Green | GREEN |  |  |
| 2307 | 1.8.10.2.9 | TORWG (Recommendation from TORWG that the Programme should enter M10) | milestone | 0d | 2025-09-16 | 2025-09-16 | 2299, 2302FS+2d, 2304FS+2d, 2281, 2282, 2390, 2300, 2301 | 2025-09-16 | 2025-09-16 | 0d | 6d | 1d |  | SI Transition | SI Transition | 333.71 | 5.27 | Matthew Breen | Green | GREEN |  |  |
| 2308 | 1.8.4.1.4 | MCAG (Confirm that the Programme can Enter M10) | milestone | 0d | 2025-09-19 | 2025-09-19 | 2307FS+2d, 2396 | 2025-09-19 | 2025-09-19 | 0d | 5d | 0d |  | SI Migration | SI Transition,SI Migration | 336.71 | 5.30 | Matthew Breen | Green | GREEN | T3-MI-0035 | MCAG (Transition) |
| 2309 | 1.8.10.2.11 | Self-Declaration from all Central Services and LDSOs that Cutover activities have been successfully carried out | milestone | 0d | 2025-09-22 | 2025-09-22 | 2308FS+1d | 2025-09-22 | 2025-09-22 | 0d | 5d | 0d |  | PP,DCC,Code Bodies | SI Transition,PP,DCC,Code Bodies | 339.71 | 5.27 | Matthew Breen | Green | GREEN |  |  |
| 2310 | 1.8.10.2.12 | Confirmation that DIP and ECS have been deployed, Service management is active, ISD has been populated | milestone | 0d | 2025-09-22 | 2025-09-22 | 2308FS+1d | 2025-09-22 | 2025-09-22 | 0d | 5d | 0d |  | Elexon,DIP Manager | SI Transition,Elexon,DIP Manager | 339.71 | 5.27 | Matthew Breen | Green | GREEN |  |  |
| 2311 | 1.8.10.2.13 | Self-Declarations against all M10 Data Cleanse Activities | milestone | 0d | 2025-09-22 | 2025-09-22 | 2308FS+1d | 2025-09-22 | 2025-09-22 | 0d | 5d | 0d |  | PP | SI Transition,PP | 339.71 | 5.27 | Matthew Breen | Green | GREEN |  |  |
| 2312 | 1.8.10.2.14 | IF-047 has been sent | milestone | 0d | 2025-09-22 | 2025-09-22 | 2308FS+1d | 2025-09-22 | 2025-09-22 | 0d | 5d | 0d |  | ECS | SI Transition,ECS | 339.71 | 5.27 | Matthew Breen | Green | GREEN |  |  |
| 2313 | 1.8.10.2.15 | Recommendation from TORWG that PSG should approve M10 | milestone | 0d | 2025-09-23 | 2025-09-23 | 2309FS+1d, 2310FS+1d, 2311FS+1d, 2312FS+1d, 2394 | 2025-09-23 | 2025-09-23 | 0d | 5d | 0d |  | SI Transition | SI Transition | 340.71 | 5.27 | Matthew Breen | Green | GREEN |  |  |
| 2314 | 1.8.10.2.16 | PSG (OFGEM and PSG to Approve That Conditions of M10 and M13 Have Been Met) | milestone | 0d | 2025-09-24 | 2025-09-24 | 2313FS+1d | 2025-09-24 | 2025-09-24 | 0d | 5d | 0d |  | SI Transition,Ofgem | SI Transition,Ofgem | 341.71 | 5.27 | Matthew Breen | Green | GREEN |  |  |
| 2315 | 1.8.10.3 | **Cutover Governance M11** |  | 19d | 2025-09-26 | 2025-10-22 |  | 2025-09-26 | 2025-10-22 |  | 5d |  |  |  |  | -687.67 |  |  | Overdue Start | RED |  |  |
| 2316 | 1.8.10.3.1 | Confirmation of Qualified Parties from Code Bodies |  | 11d | 2025-09-26 | 2025-10-10 | 2314FS+1d | 2025-09-26 | 2025-10-10 | 11d | 5d | 0d |  | Code Bodies,SIT Participants | SI Transition,Code Bodies,SIT Participants | 343.33 | 5.27 | Matthew Breen | Green | GREEN |  |  |
| 2317 | 1.8.10.3.2 | Self-Declaration that MHHS Functionality will be deployed to Production by Qualified parties | milestone | 0d | 2025-10-10 | 2025-10-10 | 2314FS+12d | 2025-10-10 | 2025-10-10 | 0d | 5d | 0d |  | PP | SI Transition,PP | 357.71 | 5.27 | Matthew Breen | Green | GREEN |  |  |
| 2318 | 1.8.10.3.3 | Production Service Activation Activities have taken place | milestone | 0d | 2025-10-10 | 2025-10-10 | 2314FS+12d | 2025-10-10 | 2025-10-10 | 0d | 5d | 0d |  | PP | SI Transition,PP | 357.71 | 5.27 | Matthew Breen | Green | GREEN |  |  |
| 2319 | 1.8.10.3.4 | TORWG (Confirmation of Qualified Parties from TORWG) | milestone | 0d | 2025-10-13 | 2025-10-13 | 2316FS+1d, 2317FS+1d, 2318FS+1d, 2297, 2391, 2395 | 2025-10-13 | 2025-10-13 | 0d | 5d | 0d |  | SI Transition | SI Transition | 360.71 | 5.27 | Matthew Breen | Green | GREEN |  |  |
| 2320 | 1.8.10.3.5 | MCAG (Provide recommendation to PSG on M11 decision) | milestone | 0d | 2025-10-17 | 2025-10-17 | 2319FS+4d | 2025-10-17 | 2025-10-17 | 0d | 5d | 0d |  | SI Migration | SI Transition,SI Migration | 364.71 | 5.30 | Matthew Breen | Green | GREEN | T3-MI-0036 | MCAG (Transition) |
| 2321 | 1.8.10.3.6 | PSG (OFGEM and PSG Decision to Confirm M11 and M12) | milestone | 0d | 2025-10-22 | 2025-10-22 | 2320FS+3d | 2025-10-22 | 2025-10-22 | 0d | 5d | 0d |  | SI Transition | SI Transition | 369.71 | 5.27 | Matthew Breen | Green | GREEN |  |  |

Notes:
- 2308: 18/6: New T3 milestone agreed at MCAG on 4/6/24 / Guidance: 25/7/24: New Milestone approved at MCAG on 25/7/24. It was initially approved at MCAG on 4/6 but didn't follow the usual process so addded to July MCAG for noting
- 2318: Guidance: 12/8/24: Think this is covered in Service activation prep section below
- 2320: 18/6: New T3 milestone agreed at MCAG on 4/6/24 / Guidance: 25/7/24: New Milestone approved at MCAG on 25/7/24. It was initially approved at MCAG on 4/6 but didn't follow the usual process so addded to July MCAG for noting

| ID | WBS | Task | Type | Duration | Start | Finish | Predecessors | Complete | Remaining | Baseline start | Baseline finish | Baseline duration | Baseline 1 start | Baseline 1 finish | Total slack | Free slack | Constraint | Baseline cost | Responsible | Involved | Task Status | Update Version | MHHS Resource Name | Sched Status | RAG | MHHS Programme Phase |
| --- | --- | --- | --- | --- | --- | --- | --- | --- | --- | --- | --- | --- | --- | --- | --- | --- | --- | --- | --- | --- | --- | --- | --- | --- | --- | --- |
| 2322 | 1.8.11 | **UMS / Advanced Migration** |  | 402d | 2025-10-23 | 2027-05-07 |  |  |  | 2025-10-23 | 2027-05-07 | 391d |  |  | 0d |  |  | -0 | N/A | N/A | -555.67 | 5.24 | N/A |  |  |  |
| 2323 | 1.8.11.1 | SIT MVC UMS / Advanced Migration |  | 391d | 2025-10-23 | 2027-04-22 | 2396, 2352 |  |  | 2025-10-23 | 2027-04-22 | 391d |  |  | 11d | 0d |  |  |  |  | 370.33 | 5.24 |  | Green | GREEN |  |
| 2324 | 1.8.11.2 | SIT Non-MVC UMS / Advanced Migration |  | 326d | 2026-01-02 | 2027-04-02 | 2417 |  |  | 2026-01-02 | 2027-04-02 | 326d |  |  | 25d |  |  |  |  |  | 441.33 | 5.24 |  | Green | GREEN |  |
| 2325 | 1.8.11.3 | Wave 1 UMS / Advanced Migration |  | 251d | 2026-05-15 | 2027-04-30 | 2433 |  |  | 2026-05-15 | 2027-04-30 | 261d |  |  | 5d |  |  |  |  |  | 574.33 | 5.24 |  | Green | GREEN |  |
| 2326 | 1.8.11.4 | Wave 2 UMS / Advanced Migration |  | 217d | 2026-07-01 | 2027-04-29 | 2457 |  |  | 2026-07-01 | 2027-04-29 | 216d |  |  | 6d |  |  |  |  |  | 621.33 | 5.24 |  | Green | GREEN |  |
| 2327 | 1.8.11.5 | Wave 3 UMS / Advanced Migration |  | 182d | 2026-08-27 | 2027-05-07 | 2481 |  |  | 2026-08-27 | 2027-05-07 | 181d |  |  | 0d |  |  |  |  |  | 678.33 | 5.24 |  | Green | GREEN |  |
| 2328 | 1.8.11.6 | Wave 4 UMS / Advanced Migration |  | 136d | 2026-10-23 | 2027-04-30 | 2505 |  |  | 2026-10-23 | 2027-04-30 | 131d |  |  | 5d |  |  |  |  |  | 735.33 | 5.24 |  | Green | GREEN |  |
| 2329 | 1.8.12 | **Smart / Non-Smart Migration** |  | 402d | 2025-10-23 | 2027-05-07 |  |  |  | 2025-10-23 | 2027-05-07 | 391d |  |  | 0d |  |  | -0 | N/A | N/A | -555.67 | 5.24 | N/A |  |  |  |
| 2330 | 1.8.12.1 | SIT MVC Smart / Non-Smart Migration |  | 391d | 2025-10-23 | 2027-04-22 | 2396, 2352 |  |  | 2025-10-23 | 2027-04-22 | 391d |  |  | 11d | 0d |  |  |  |  | 370.33 | 5.24 |  | Green | GREEN |  |
| 2331 | 1.8.12.2 | SIT Non-MVC Smart / Non-Smart Migration |  | 326d | 2026-01-02 | 2027-04-02 | 2417 |  |  | 2026-01-02 | 2027-04-02 | 326d |  |  | 25d |  |  |  |  |  | 441.33 | 5.24 |  | Green | GREEN |  |
| 2332 | 1.8.12.3 | Wave 1 Smart / Non-Smart Migration |  | 251d | 2026-05-15 | 2027-04-30 | 2433 |  |  | 2026-05-15 | 2027-04-30 | 261d |  |  | 5d |  | start no earlier than 2025-10-03 |  |  |  | 574.33 | 5.24 |  | Green | GREEN |  |
| 2333 | 1.8.12.4 | Wave 2 Smart / Non-Smart Migration |  | 217d | 2026-07-01 | 2027-04-29 | 2457 |  |  | 2026-07-01 | 2027-04-29 | 216d |  |  | 6d |  |  |  |  |  | 621.33 | 5.24 |  | Green | GREEN |  |
| 2334 | 1.8.12.5 | Wave 3 Smart / Non-Smart Migration |  | 182d | 2026-08-27 | 2027-05-07 | 2481 |  |  | 2026-08-27 | 2027-05-07 | 181d |  |  | 0d |  |  |  |  |  | 678.33 | 5.24 |  | Green | GREEN |  |
| 2335 | 1.8.12.6 | Wave 4 Smart / Non-Smart Migration |  | 136d | 2026-10-23 | 2027-04-30 | 2505 |  |  | 2026-10-23 | 2027-04-30 | 131d |  |  | 4d |  |  |  |  |  | 735.33 | 5.24 |  | Green | GREEN |  |
| 2336 | 1.8.13 | **External Programme Dependency Management** |  | 740d | 2022-10-31 A | 2025-08-29 |  | 66% | 253.44d | 2022-10-31 | 2025-08-29 | 827d | 2022-10-31 | 2025-07-01 | 604d |  |  | -0 | N/A | N/A |  | 5.0 | N/A |  |  | Migration |
| 2337 | 1.8.13.1 | **BSC Mod P432 & REC CP R0015** |  | 392d | 2022-10-31 A | 2024-04-30 A |  | 100% |  | 2022-10-31 | 2024-04-30 | 827d | 2022-10-31 | 2025-07-01 |  |  |  | -0 | N/A | N/A |  | 5.0 | N/A |  |  | Migration |
| 2338 | 1.8.13.1.1 | MHHSP engagement with BSCCo until Ofgem decision |  | 316d | 2022-10-31 A | 2024-01-15 A |  | 100% |  | 2022-10-31 | 2024-01-15 | 400d | 2022-10-31 | 2022-12-30 |  |  |  |  | CPT,SRO Function | Code Bodies |  | 5.0 | MHHS Programme | Complete | COMPLETE | Migration |
| 2339 | 1.8.13.1.2 | Monitor progress and await implementation date |  | 76d | 2024-01-16 A | 2024-04-30 A | 2338 | 100% |  | 2024-01-16 | 2024-04-30 | 652d | 2023-01-02 | 2025-07-01 |  |  |  |  | CPT,SRO Function | Code Bodies |  | 5.0 | MHHS Programme | Complete | COMPLETE | Migration |
| 2340 | 1.8.13.2 | **BSC Mod P434** |  | 713d | 2022-10-31 A | 2025-07-23 |  | 57% | 310d | 2022-10-31 | 2025-07-23 | 713d | 2022-10-31 | 2025-07-01 | 631d |  |  |  | N/A | N/A |  | 5.0 | N/A |  |  | Migration |
| 2341 | 1.8.13.2.1 | MHHSP engagement with BSCCo until Ofgem decision |  | 61d | 2022-10-31 A | 2023-01-23 A |  | 100% |  | 2022-10-31 | 2023-01-23 | 61d | 2022-10-31 | 2022-12-30 |  |  |  |  | CPT,SRO Function | Code Bodies |  | 5.0 | MHHS Programme | Complete | COMPLETE | Migration |
| 2342 | 1.8.13.2.2 | Monitor progress and await implementation date |  | 652d | 2023-01-24 A | 2025-07-23 | 2341 | 52% | 310d | 2023-01-24 | 2025-07-23 | 652d | 2023-01-02 | 2025-07-01 | 631d |  |  |  | CPT,SRO Function | Code Bodies |  | 5.0 | MHHS Programme | Green | GREEN | Migration |
| 2343 | 1.8.13.3 | **Elexon System Capacity Upgrade** |  | 697d | 2022-10-31 A | 2025-07-01 |  | 58% | 294d | 2022-10-31 | 2025-07-01 | 697d | 2022-10-31 | 2025-07-01 | 647d |  |  |  | N/A | N/A |  | 5.0 | N/A |  |  | Migration |
| 2344 | 1.8.13.3.1 | Monitor progress to implementation |  | 697d | 2022-10-31 A | 2025-07-01 |  | 58% | 294d | 2022-10-31 | 2025-07-01 | 697d | 2022-10-31 | 2025-07-01 | 647d | 0d |  |  | SI Migration | PP |  | 5.0 | MHHS Programme | Green | GREEN | Migration |
| 2345 | 1.8.13.3.2 | Implementation date | milestone | 0d | 2025-07-01 | 2025-07-01 | 2344 |  |  | 2025-07-01 | 2025-07-01 | 0d | 2025-07-01 | 2025-07-01 | 647d |  |  |  | PP | SI Migration | 256.71 | 5.0 | MHHS Programme | Green | GREEN | Migration |

Notes:
- 2325: Guidance: 12/8/24: Made start no earlier, because shorter service actiobal was allowing this to start earlier than the date that had been set
- 2332: Guidance: 12/8/24: Made start no earlier, because shorter service actiobal was allowing this to start earlier than the date that had been set

| ID | WBS | Task | Type | Duration | Start | Finish | Predecessors | Complete | Remaining | Baseline start | Baseline finish | Baseline duration | Baseline 1 start | Baseline 1 finish | Total slack | Free slack | Constraint | Baseline cost | Responsible | Involved | Update Version | MHHS Resource Name | MHHS Programme Phase | Task Status | Sched Status | RAG | Milestone ID | Text29 | Tier | Text3 | Notes (2) |
| --- | --- | --- | --- | --- | --- | --- | --- | --- | --- | --- | --- | --- | --- | --- | --- | --- | --- | --- | --- | --- | --- | --- | --- | --- | --- | --- | --- | --- | --- | --- | --- |
| 2346 | 1.8.13.4 | **DCC System Capacity Upgrade** |  | 25d | 2025-07-28 | 2025-08-29 |  |  |  | 2025-07-28 | 2025-08-29 | 25d | 2025-01-13 | 2025-02-14 | 604d |  |  |  | N/A | N/A | 5.0 | N/A | Migration |  |  |  |  |  |  |  |  |
| 2347 | 1.8.13.4.1 | Assurance of DCC capacity upgrade to ensure suitability to support migration |  | 20d | 2025-07-28 | 2025-08-22 | 1493FF-23d |  |  | 2025-07-28 | 2025-08-22 | 20d | 2025-01-13 | 2025-02-07 | 604d | 0d |  |  | SI Migration | PP | 5.0 | MHHS Programme | Migration | 283.33 | Green | GREEN |  |  |  |  |  |
| 2348 | 1.8.13.4.2 | DCC Capacity Upgrade Operational | milestone | 0d | 2025-08-29 | 2025-08-29 | 2347FS+5d |  |  | 2025-08-29 | 2025-08-29 | 0d | 2025-02-14 | 2025-02-14 | 604d |  |  |  | PP | SI Migration,IPA | 5.0 | MHHS Programme | Migration | 315.71 | Green | GREEN | T2-MI-0350 | MCAG | T2 |  |  |
| 2349 | 1.8.14 | **Migration - Tier 1 Milestones** |  | 488d | 2025-09-24 | 2027-08-09 |  |  |  | 2025-09-24 | 2027-08-09 | 477d | 2025-03-07 | 2027-01-05 | 25d |  |  |  | N/A | N/A | 5.0 | N/A | Migration |  |  |  |  |  |  |  |  |
| 2350 | 1.8.14.1 | Load Shaping Service switched on (M13) | milestone | 0d | 2025-09-24 | 2025-09-24 | 1493 |  |  | 2025-09-24 | 2025-09-24 | 0d | 2025-03-07 | 2025-03-07 | 25d | 0d |  |  | CPT | CPT | 6.1 | CPT | Migration | 341.71 | Green | GREEN | T1-MI-2000 | PSG | T1 | Load Shaping Service switched on |  |
| 2351 | 1.8.14.2 | Load Shaping Service switched on (M13*) - Late Exit | milestone | 0d | 2025-12-24 | 2025-12-24 | 2350FS+65d |  |  | 2025-12-24 | 2025-12-24 | 0d | 2025-06-06 | 2025-06-06 | 521d |  |  |  | CPT | CPT | 5.0 | CPT | Migration | 432.71 | Green | GREEN | T2-MI-2500 | PSG | T1 | Load Shaping Service switched on |  |
| 2352 | 1.8.14.3 | Start of 18-month migration for UMS / Advanced (M11) | milestone | 0d | 2025-10-22 | 2025-10-22 | 2350, 2320, 2321, 2396, 1493FS+20d |  |  | 2025-10-22 | 2025-10-22 | 0d | 2025-04-04 | 2025-04-04 | 5d | 0d |  |  | CPT | CPT | 6.1 | CPT | Migration | 369.71 | Green | GREEN | T1-MI-3000 | PSG | T1 | Start of 1 year migration for UMS / Advanced |  |
| 2353 | 1.8.14.4 | Start of 18-month migration for UMS / Advanced (M11*) - Late Exit | milestone | 0d | 2026-01-21 | 2026-01-21 | 2352FS+65d |  |  | 2026-01-21 | 2026-01-21 | 0d | 2025-07-04 | 2025-07-04 | 501d |  |  |  | CPT | CPT | 5.0 | CPT | Migration | 460.71 | Green | GREEN | T2-MI-3500 | PSG | T1 | Start of 1 year migration for UMS / Advanced |  |
| 2354 | 1.8.14.5 | Start of 18-month migration for Smart / Non-smart (M12) | milestone | 0d | 2025-10-22 | 2025-10-22 | 2350, 1493FS+20d |  |  | 2025-10-22 | 2025-10-22 | 0d | 2025-04-04 | 2025-04-04 | 501d | 0d |  |  | CPT | CPT | 6.1 | CPT | Migration | 369.71 | Green | GREEN | T1-MI-4000 | PSG | T1 | Start of 1 year migration for Smart / Non-smart |  |
| 2355 | 1.8.14.6 | Start of 18-month migration for Smart / Non-smart (M12*) - Late Exit | milestone | 0d | 2026-01-21 | 2026-01-21 | 2354FS+65d |  |  | 2026-01-21 | 2026-01-21 | 0d | 2025-07-04 | 2025-07-04 | 501d |  |  |  | CPT | CPT | 5.0 | CPT | Migration | 460.71 | Green | GREEN | T2-MI-4500 | PSG | T1 | Start of 1 year migration for Smart / Non-smart |  |
| 2356 | 1.8.14.7 | Full transition complete (M15) | milestone | 0d | 2027-05-07 | 2027-05-07 | 2323, 2324, 2325, 2326, 2327, 2328, 2330, 2331, 2332, 2333, 2334, 2335FS+1d |  |  | 2027-05-07 | 2027-05-07 | 0d | 2026-10-05 | 2026-10-05 | 0d |  |  |  | CPT | CPT | 6.1 | CPT | Migration | 931.71 | Green | GREEN | T1-MI-6000 | PSG | T1 | Full transition complete |  |
| 2357 | 1.8.14.8 | Full transition complete (M15*) - Late Exit | milestone | 0d | 2027-08-09 | 2027-08-09 | 2356FS+66d |  |  | 2027-08-09 | 2027-08-09 | 0d | 2027-01-05 | 2027-01-05 | 98d |  |  |  | CPT | CPT | 5.0 | CPT | Migration | 1025.71 | Green | GREEN | T2-MI-6500 | PSG | T1 | Full transition complete |  |
| 2358 | 1.9 | **BUSINESS & OPERATIONAL READINESS** |  | 1344d? | 2022-10-31 A | 2027-12-23 |  | 6% | 1268.73d? | 2022-10-31 | 2027-12-23 | 964d | 2023-03-01 | 2026-12-07 | 0d |  |  | -0 | N/A | N/A |  | N/A | Business & Operational Readiness |  |  |  |  |  |  |  |  |
| 2359 | 1.9.1 | **Service Management** |  | 983d | 2023-09-19 A | 2027-06-24 |  | 26% | 728.35d | 2023-09-19 | 2027-06-24 | 840d | 2023-03-01 | 2026-12-07 | 130d |  |  | -0 | N/A | N/A | 5.0 | N/A | Business & Operational Readiness |  |  |  |  |  |  |  |  |
| 2360 | 1.9.1.1 | **Service Management Strategy** |  | 116d | 2023-09-19 A | 2024-02-27 A |  | 100% |  | 2023-09-19 | 2024-02-27 | 116d | 2023-03-01 | 2023-05-31 |  |  |  | -0 | N/A | N/A | 5.0 | N/A | Business & Operational Readiness |  |  |  |  |  |  |  |  |
| 2361 | 1.9.1.1.1 | Develop document with relevant participants (incl. review of the design baseline to ensure service management arrangements are in place across the solution architecture) |  | 84d | 2023-09-19 A | 2024-01-12 A |  | 100% |  | 2023-09-19 | 2024-01-12 | 84d | 2023-03-01 | 2023-04-28 |  |  | start no earlier than 2023-09-19 |  | SI Design |  | 5.0 | Matthew Breen | Business & Operational Readiness |  | Complete | COMPLETE |  |  |  |  |  |
| 2362 | 1.9.1.1.2 | Artefact review (via relevant Advisory Group) and updates |  | 31d | 2024-01-15 A | 2024-02-26 A | 2361 | 100% |  | 2024-01-15 | 2024-02-26 | 31d | 2023-05-01 | 2023-05-24 |  |  |  |  | PP | SI Design,IPA | 5.0 | Matthew Breen | Business & Operational Readiness |  | Complete | COMPLETE |  |  |  |  |  |
| 2363 | 1.9.1.1.3 | Service Management Strategy approved | milestone | 0d | 2024-02-27 A | 2024-02-27 A | 2362FS+1d | 100% |  | 2024-02-27 | 2024-02-27 | 0d | 2023-05-31 | 2023-05-31 |  |  |  |  | SI Design | PP | 5.16 | Matthew Breen | Business & Operational Readiness |  | Complete | COMPLETE | T3-BC-0010 | MCAG | T3 |  |  |
| 2364 | 1.9.1.2 | **Early Life Support Model** |  | 110d | 2024-02-28 A | 2024-07-30 |  | 82% | 20.23d | 2024-02-28 | 2024-07-30 | 110d |  |  | 842d |  |  | -0 | N/A | N/A | 5.16 | N/A | Business & Operational Readiness | -441.67 |  |  |  |  |  |  |  |
| 2365 | 1.9.1.2.1 | Draft Document |  | 74d | 2024-02-28 A | 2024-06-10 | 2363 | 96% | 3d | 2024-02-28 | 2024-06-10 | 74d |  |  | 842d | 0d |  |  | SI Transition | SI Transition,PP,SRO | 5.24 | Matthew Breen | Business & Operational Readiness |  | Overdue | RED |  |  |  |  |  |
| 2366 | 1.9.1.2.2 | Share document with SRO |  | 1d | 2024-06-11 | 2024-06-11 | 2365 |  |  | 2024-06-11 | 2024-06-11 | 1d |  |  | 842d | 0d |  |  | SI Transition | SI Transition,PP,SRO | 5.24 | Matthew Breen | Business & Operational Readiness | -128.67 | Overdue Start | RED |  |  |  |  |  |
| 2367 | 1.9.1.2.3 | Industry Consultation |  | 11d | 2024-06-18 | 2024-07-02 | 2366FS+4d |  |  | 2024-06-18 | 2024-07-02 | 11d |  |  | 842d | 0d |  |  | SI Transition | SI Transition,PP,SRO | 5.24 | Matthew Breen | Business & Operational Readiness | -121.67 | Overdue Start | RED |  |  |  |  |  |
| 2368 | 1.9.1.2.4 | Assurance Meeting |  | 1d | 2024-07-16 | 2024-07-16 | 2367FS+9d |  |  | 2024-07-16 | 2024-07-16 | 1d |  |  | 842d | 0d |  |  | SI Transition | SI Transition,PP,SRO | 5.24 | Matthew Breen | Business & Operational Readiness | -93.67 | Overdue Start | RED |  |  |  |  |  |
| 2369 | 1.9.1.2.5 | MCAG Approval of Early Life Support Model | milestone | 0d | 2024-07-30 | 2024-07-30 | 2368FS+10d |  |  | 2024-07-30 | 2024-07-30 | 0d |  |  | 842d | 113d |  |  | SI Transition | PP,SRO,SI Transition | 5.24 | Matthew Breen | Business & Operational Readiness | -79.29 | Overdue Start | RED | T3-MI-0033 | MCAG (Transition) |  |  | been held with the Code Bodies at the end of August |

Notes:
- 2363: 17/1 - Baseline change approved at TMAG to change date from 21/2/24 to 27/2/24. Changed because MCAG has been scheduled for 27/2/24. Approved at TMAG on 7/1/24
- 2369: Consultation has been delayed until November 2024.

| ID | WBS | Task | Type | Duration | Start | Finish | Predecessors | Baseline start | Baseline finish | Baseline duration | Baseline 1 start | Baseline 1 finish | Total slack | Free slack | Constraint | Baseline cost | Responsible | Involved | Update Version | MHHS Resource Name | MHHS Programme Phase | Task Status | Sched Status | RAG |
| --- | --- | --- | --- | --- | --- | --- | --- | --- | --- | --- | --- | --- | --- | --- | --- | --- | --- | --- | --- | --- | --- | --- | --- | --- |
| 2370 | 1.9.1.3 | **Service Management Arrangements Implementation** |  | 456d | 2025-09-25 | 2027-06-24 |  | 2025-09-25 | 2027-06-24 | 453d | 2025-03-10 | 2026-12-07 | 130d |  |  | -0 | N/A | N/A | 5.0 | N/A | Business & Operational Readiness |  |  |  |
| 2371 | 1.9.1.3.1 | Hypercare post M10 |  | 80d | 2025-09-25 | 2026-01-14 | 1493 | 2025-09-25 | 2026-01-14 | 80d | 2025-03-10 | 2025-06-27 | 506d |  |  |  | SI Design | PP | 5.0 | Claire Silk | Business & Operational Readiness | 342.33 | Green | GREEN |
| 2372 | 1.9.1.3.2 | Monitor Elexon implementation of Service Management arrangements |  | 436d | 2025-10-23 | 2027-06-24 | 2323SS, 2330SS | 2025-10-23 | 2027-06-24 | 436d | 2025-04-07 | 2026-12-07 | 130d |  |  |  | PP | SI Design | 5.0 | Claire Silk | Business & Operational Readiness | 370.33 | Green | GREEN |
| 2373 | 1.9.2 | **Service Activation** |  | 1039d? | 2022-10-31 | 2026-10-22 |  | 2022-10-31 | 2026-10-22 | 289d |  |  | 305d |  |  | -0 | N/A | N/A | 5.24 | N/A |  | -555.67 |  |  |
| 2374 | 1.9.2.1 | **SIT MVC** |  | 166d? | 2025-02-03 | 2025-09-22 |  | 2025-02-03 | 2025-09-22 | 0d |  |  | 163d |  |  |  |  |  | 5.31 |  |  | -650.67 | Overdue Start | RED |
| 2375 | 1.9.2.1.1 | **SIT MVC Service Activation Preparation Tasks** |  | 20d | 2025-02-03 | 2025-02-28 |  | 2025-02-03 | 2025-02-28 | 0d |  |  | 164d |  |  |  |  |  | 5.31 |  |  |  |  |  |
| 2376 | 1.9.2.1.1.1 | Identify operational resources |  | 5d | 2025-02-03 | 2025-02-07 |  | 2025-02-03 | 2025-02-07 | 0d |  |  | 749d |  | finish no earlier than 2025-02-07 |  |  |  | 5.31 |  |  | 108.33 | Green | GREEN |
| 2377 | 1.9.2.1.1.2 | Define and approve operational support model |  | 5d | 2025-02-10 | 2025-02-14 |  | 2025-02-10 | 2025-02-14 | 0d |  |  | 744d |  | finish no earlier than 2025-02-14 |  |  |  | 5.31 |  |  | 115.33 | Green | GREEN |
| 2378 | 1.9.2.1.1.3 | Confirm SA Training completed |  | 10d | 2025-02-10 | 2025-02-21 |  | 2025-02-10 | 2025-02-21 | 0d |  |  | 739d |  | finish no earlier than 2025-02-21 |  |  |  | 5.31 |  |  | 115.33 | Green | GREEN |
| 2379 | 1.9.2.1.1.4 | Participant Engagement / Communications |  | 15d | 2025-02-10 | 2025-02-28 |  | 2025-02-10 | 2025-02-28 | 0d |  |  | 734d |  | finish no earlier than 2025-02-28 |  |  |  | 5.31 |  |  | 115.33 | Green | GREEN |
| 2380 | 1.9.2.1.1.5 | Internal Communications |  | 15d | 2025-02-10 | 2025-02-28 |  | 2025-02-10 | 2025-02-28 | 0d |  |  | 734d |  | finish no earlier than 2025-02-28 |  |  |  | 5.31 |  |  | 115.33 | Green | GREEN |
| 2381 | 1.9.2.1.1.6 | Validate User Access |  | 5d | 2025-02-17 | 2025-02-21 |  | 2025-02-17 | 2025-02-21 | 0d |  |  | 739d |  | finish no earlier than 2025-02-21 |  |  |  | 5.31 |  |  | 122.33 | Green | GREEN |
| 2382 | 1.9.2.1.1.7 | Target Systems and Environments Ready |  | 3d | 2025-02-20 | 2025-02-24 |  | 2025-02-20 | 2025-02-24 | 0d |  |  | 738d |  | finish no earlier than 2025-02-24 |  | HELIX |  | 5.31 |  |  | 125.33 | Green | GREEN |
| 2383 | 1.9.2.1.1.8 | Provide opeartional resources with LWIs |  | 5d | 2025-02-17 | 2025-02-21 |  | 2025-02-17 | 2025-02-21 | 0d |  |  | 739d |  | finish no earlier than 2025-02-21 |  |  |  | 5.31 |  |  | 122.33 | Green | GREEN |
| 2384 | 1.9.2.1.1.9 | Business Readiness Governance Approval |  | 3d | 2025-02-17 | 2025-02-19 |  | 2025-02-17 | 2025-02-19 | 0d |  |  | 741d |  | finish no earlier than 2025-02-19 |  |  |  | 5.31 |  |  | 122.33 | Green | GREEN |
| 2385 | 1.9.2.1.1.10 | SIT MVC Service Activation Preparation Tasks Complete | milestone | 0d | 2025-02-28 | 2025-02-28 |  | 2025-02-28 | 2025-02-28 | 0d |  |  | 144d | 139d | finish no earlier than 2025-02-28 |  |  |  | 5.31 |  |  | 133.71 | Green | GREEN |
| 2386 | 1.9.2.1.2 | MHHSP Confirms SIT MVC PPs MHHS Enabled |  | 1d | 2025-04-15 | 2025-04-15 | 2294 | 2025-04-15 | 2025-04-15 | 0d |  |  | 112d | 107d |  |  |  |  | 5.28 |  |  | 179.33 | Green | GREEN |
| 2387 | 1.9.2.1.3 | **SIT MVC Service Activation Implementation** |  | 7d? | 2025-09-12 | 2025-09-22 |  | 2025-09-12 | 2025-09-22 | 0d |  |  | 5d |  |  |  |  |  | 5.31 |  |  |  |  |  |
| 2388 | 1.9.2.1.3.1 | Add EDF to DIP |  | 1d | 2025-09-12 | 2025-09-12 | 1687SS, 2386, 2385 | 2025-09-12 | 2025-09-12 | 0d |  |  | 5d | 0d |  |  |  |  | 5.31 |  |  | 329.33 | Green | GREEN |
| 2389 | 1.9.2.1.3.2 | DIP Promoted to Production |  | 1d? | 2025-09-15 | 2025-09-15 | 2388 | 2025-09-15 | 2025-09-15 |  |  |  | 5d | 0d |  |  |  |  | 5.31 |  |  | 332.33 | Green | GREEN |
| 2390 | 1.9.2.1.3.3 | SIT LDSOs Create Certificates and Test Connectivity |  | 1d? | 2025-09-16 | 2025-09-16 | 2389 | 2025-09-16 | 2025-09-16 |  |  |  | 6d | 0d |  |  |  |  | 5.31 |  |  | 333.33 | Green | GREEN |
| 2391 | 1.9.2.1.3.4 | SIT MVC S&As Create Certificates and Test Connectivity |  | 1d? | 2025-09-16 | 2025-09-16 | 2389 | 2025-09-16 | 2025-09-16 |  |  |  | 24d | 19d |  |  |  |  | 5.31 |  |  | 333.33 | Green | GREEN |
| 2392 | 1.9.2.1.3.5 | Create M16 in Customer Solution |  | 2d | 2025-09-16 | 2025-09-17 | 2389 | 2025-09-16 | 2025-09-17 | 0d |  |  | 5d | 0d | finish no earlier than 2025-03-07 |  |  |  | 5.31 |  |  | 333.33 | Green | GREEN |
| 2393 | 1.9.2.1.3.6 | Publish ISD |  | 2d | 2025-09-18 | 2025-09-19 | 2392 | 2025-09-18 | 2025-09-19 | 0d |  |  | 5d | 0d | finish no earlier than 2025-03-07 |  |  |  | 5.31 |  |  | 335.33 | Green | GREEN |
| 2394 | 1.9.2.1.3.7 | SIT LDSOs to update systems with ISD |  | 1d? | 2025-09-22 | 2025-09-22 | 2393 | 2025-09-22 | 2025-09-22 |  |  |  | 6d | 1d |  |  |  |  | 5.31 |  |  | 339.33 | Green | GREEN |
| 2395 | 1.9.2.1.3.8 | SIT MVC S&As to update systems with ISD |  | 1d? | 2025-09-22 | 2025-09-22 | 2393 | 2025-09-22 | 2025-09-22 |  |  |  | 20d | 15d |  |  |  |  | 5.31 |  |  | 339.33 | Green | GREEN |
| 2396 | 1.9.2.1.3.9 | SIT MVC Service Activation Implementation Complete | milestone | 0d | 2025-09-19 | 2025-09-19 | 2393 | 2025-09-19 | 2025-09-19 | 0d |  |  | 5d | 0d | finish no earlier than 2025-03-07 |  |  |  | 5.31 |  |  | 336.71 | Green | GREEN |

Notes:
- 2371: 10/5: Detail to be added when available
- 2372: 10/5: Detail to be added when available
- 2373: 8/7/24: Likely Servce action will be on a pp by pp basis
- 2386: 8/7/24: For M11 need mcc enabled - need confirmation suppliers agree to being mhhs enabled
- 2392: 18/09/24 - This milestone is consistent with the Service Activation Verison 2.0 Process Map.

| ID | WBS | Task | Type | Duration | Start | Finish | Predecessors | Baseline start | Baseline finish | Baseline duration | Total slack | Free slack | Constraint | Update Version | Task Status | Sched Status | RAG | Involved |
| --- | --- | --- | --- | --- | --- | --- | --- | --- | --- | --- | --- | --- | --- | --- | --- | --- | --- | --- |
| 2397 | 1.9.2.1.4 | **SIT MVC Service Activation Implementation MDD** |  | 14d | 2025-03-06 | 2025-03-25 |  | 2025-03-06 | 2025-03-25 | 0d | 717d |  |  | 5.31 |  |  |  |  |
| 2398 | 1.9.2.1.4.1 | MDD Manual Load |  | 7d | 2025-03-06 | 2025-03-14 |  | 2025-03-06 | 2025-03-14 | 0d | 724d |  | finish no earlier than 2025-03-14 | 5.31 | 139.33 | Green | GREEN |  |
| 2399 | 1.9.2.1.4.2 | MDD Update |  | 8d | 2025-03-14 | 2025-03-25 |  | 2025-03-14 | 2025-03-25 | 0d | 717d |  | finish no earlier than 2025-03-25 | 5.31 | 147.33 | Green | GREEN |  |
| 2400 | 1.9.2.1.4.3 | SIT MVC Service Activation Implementation MDD Complete | milestone | 0d | 2025-03-25 | 2025-03-25 |  | 2025-03-25 | 2025-03-25 | 0d | 717d |  | finish no earlier than 2025-03-25 | 5.31 | 158.71 | Green | GREEN |  |
| 2401 | 1.9.2.1.5 | **SIT MVC Service Activation Hypercare** |  | 18d | 2025-03-03 | 2025-03-26 |  | 2025-03-03 | 2025-03-26 | 0d | 716d |  |  | 5.31 |  |  |  |  |
| 2402 | 1.9.2.1.5.1 | Service & Process Monitoring |  | 18d | 2025-03-03 | 2025-03-26 |  | 2025-03-03 | 2025-03-26 | 0d | 716d |  | finish no earlier than 2025-03-26 | 5.31 | 136.33 | Green | GREEN |  |
| 2403 | 1.9.2.1.5.2 | Daily Reporting |  | 18d | 2025-03-03 | 2025-03-26 |  | 2025-03-03 | 2025-03-26 | 0d | 716d |  | finish no earlier than 2025-03-26 | 5.31 | 136.33 | Green | GREEN |  |
| 2404 | 1.9.2.1.5.3 | Issue Management |  | 18d | 2025-03-03 | 2025-03-26 |  | 2025-03-03 | 2025-03-26 | 0d | 716d |  | finish no earlier than 2025-03-26 | 5.31 | 136.33 | Green | GREEN |  |
| 2405 | 1.9.2.1.5.4 | SA Hypercare Close Down Activities |  | 18d | 2025-03-03 | 2025-03-26 |  | 2025-03-03 | 2025-03-26 | 0d | 716d |  | finish no earlier than 2025-03-26 | 5.31 | 136.33 | Green | GREEN |  |
| 2406 | 1.9.2.1.5.5 | Handover to MHHSP |  | 3d | 2025-03-21 | 2025-03-25 |  | 2025-03-21 | 2025-03-25 | 0d | 717d |  | finish no earlier than 2025-03-25 | 5.31 | 154.33 | Green | GREEN | MHHSP |
| 2407 | 1.9.2.1.5.6 | SIT MVC Service Activation Hypercare Complete | milestone | 0d | 2025-03-25 | 2025-03-25 |  | 2025-03-25 | 2025-03-25 | 0d | 717d |  | finish no earlier than 2025-03-25 | 5.31 | 158.71 | Green | GREEN |  |
| 2408 | 1.9.2.2 | **SIT Non-MVC** |  | 829d | 2022-10-31 | 2026-01-01 |  | 2022-10-31 | 2026-01-01 | 0d | 515d |  |  | 5.31 | -650.67 | Overdue Start | RED |  |
| 2409 | 1.9.2.2.1 | **SIT Non-MVC Service Activation Preparation Tasks** |  | 1d | 2022-10-31 | 2022-10-31 |  | 2022-10-31 | 2022-10-31 | 0d | 845d |  |  | 5.31 | -651.67 | Overdue Start | RED |  |
| 2410 | 1.9.2.2.1.1 | Helix Preparatory Activities Complete | milestone | 0d | 2022-10-31 | 2022-10-31 |  | 2022-10-31 | 2022-10-31 | 0d | 1344d |  |  | 5.29 | -717.67 | Overdue Start | RED |  |
| 2411 | 1.9.2.2.1.2 | MHHSP Confirms SIT Non-MVC PPs MHHS Enabled |  | 1d | 2022-10-31 | 2022-10-31 |  | 2022-10-31 | 2022-10-31 | 0d | 845d | 820d |  | 5.28 | -717.67 | Overdue Start | RED |  |
| 2412 | 1.9.2.2.2 | **SIT Non-MVC Service Activation Implementation** |  | 8d | 2025-12-23 | 2026-01-01 |  | 2025-12-23 | 2026-01-01 | 0d | 25d |  |  | 5.31 |  |  |  |  |
| 2413 | 1.9.2.2.2.1 | Add EDF to DIP |  | 2d | 2025-12-23 | 2025-12-24 | 1693SS, 2411 | 2025-12-23 | 2025-12-24 | 0d | 25d | 0d | finish no earlier than 2025-06-04 | 5.31 | 431.33 | Green | GREEN |  |
| 2414 | 1.9.2.2.2.2 | DIP Promoted to Production |  | 2d | 2025-12-25 | 2025-12-26 | 2413 | 2025-12-25 | 2025-12-26 | 0d | 25d | 0d | finish no earlier than 2025-06-05 | 5.31 | 433.33 | Green | GREEN |  |
| 2415 | 1.9.2.2.2.3 | Create M16 in Customer Solution |  | 2d | 2025-12-29 | 2025-12-30 | 2414 | 2025-12-29 | 2025-12-30 | 0d | 25d | 0d | finish no earlier than 2025-06-06 | 5.31 | 437.33 | Green | GREEN |  |
| 2416 | 1.9.2.2.2.4 | Publish ISD |  | 2d | 2025-12-31 | 2026-01-01 | 2415 | 2025-12-31 | 2026-01-01 | 0d | 25d | 0d | finish no earlier than 2025-06-06 | 5.31 | 439.33 | Green | GREEN |  |
| 2417 | 1.9.2.2.2.5 | SIT Non-MVC Service Activation Implementation Complete | milestone | 0d | 2026-01-01 | 2026-01-01 | 2416 | 2026-01-01 | 2026-01-01 | 0d | 25d | 0d | finish no earlier than 2025-06-06 | 5.31 | 440.71 | Green | GREEN |  |
| 2418 | 1.9.2.2.3 | **SIT Non-MVC Service Activation Implementation MDD** |  | 14d | 2025-06-05 | 2025-06-24 |  | 2025-06-05 | 2025-06-24 | 0d | 652d |  |  | 5.31 |  |  |  |  |
| 2419 | 1.9.2.2.3.1 | MDD Manual Load |  | 7d | 2025-06-05 | 2025-06-13 |  | 2025-06-05 | 2025-06-13 | 0d | 659d |  | finish no earlier than 2025-06-13 | 5.31 | 230.33 | Green | GREEN |  |
| 2420 | 1.9.2.2.3.2 | MDD Update |  | 8d | 2025-06-13 | 2025-06-24 |  | 2025-06-13 | 2025-06-24 | 0d | 652d |  | finish no earlier than 2025-06-24 | 5.31 | 238.33 | Green | GREEN |  |
| 2421 | 1.9.2.2.3.3 | SIT Non-MVC Service Activation Implementation MDD Complete | milestone | 0d | 2025-06-24 | 2025-06-24 |  | 2025-06-24 | 2025-06-24 | 0d | 652d |  | finish no earlier than 2025-06-24 | 5.31 | 249.71 | Green | GREEN |  |

Notes:
- 2406: Action: 12/8/24: Why is ths a dep into us?
- 2410: Action: 12/8/24: Emailed helix to clarify what needs to go in the prep section and if hypercare is required
- 2411: 8/7/24: Confirm Predecessors

| ID | WBS | Task | Type | Duration | Start | Finish | Predecessors | Baseline start | Baseline finish | Baseline duration | Total slack | Free slack | Constraint | Update Version | Task Status | Sched Status | RAG | Involved |
| --- | --- | --- | --- | --- | --- | --- | --- | --- | --- | --- | --- | --- | --- | --- | --- | --- | --- | --- |
| 2422 | 1.9.2.2.4 | **Non-SIT MVC Service Activation Hypercare** |  | 19d | 2025-06-02 | 2025-06-26 |  | 2025-06-02 | 2025-06-26 | 0d | 650d |  |  | 5.31 |  |  |  |  |
| 2423 | 1.9.2.2.4.1 | Service& Process Monitoring |  | 18d | 2025-06-02 | 2025-06-25 |  | 2025-06-02 | 2025-06-25 | 0d | 651d |  | finish no earlier than 2025-06-25 | 5.31 | 227.33 | Green | GREEN |  |
| 2424 | 1.9.2.2.4.2 | Daily Reporting |  | 18d | 2025-06-02 | 2025-06-25 |  | 2025-06-02 | 2025-06-25 | 0d | 651d |  | finish no earlier than 2025-06-25 | 5.31 | 227.33 | Green | GREEN |  |
| 2425 | 1.9.2.2.4.3 | Issue Management |  | 18d | 2025-06-02 | 2025-06-25 |  | 2025-06-02 | 2025-06-25 | 0d | 651d |  | finish no earlier than 2025-06-25 | 5.31 | 227.33 | Green | GREEN |  |
| 2426 | 1.9.2.2.4.4 | SA Hypercare Close Down Activities |  | 18d | 2025-06-02 | 2025-06-25 |  | 2025-06-02 | 2025-06-25 | 0d | 651d |  | finish no earlier than 2025-06-25 | 5.31 | 227.33 | Green | GREEN |  |
| 2427 | 1.9.2.2.4.5 | Handover to MHHSP |  | 4d | 2025-06-23 | 2025-06-26 |  | 2025-06-23 | 2025-06-26 | 0d | 650d |  | finish no earlier than 2025-06-26 | 5.31 | 248.33 | Green | GREEN | MHHSP |
| 2428 | 1.9.2.2.4.6 | Non-SIT MVC Service Activation Hypercare Complete (M) | milestone | 0d | 2025-06-25 | 2025-06-25 |  | 2025-06-25 | 2025-06-25 | 0d | 651d |  | finish no earlier than 2025-06-25 | 5.31 | 250.71 | Green | GREEN |  |
| 2429 | 1.9.2.3 | **Wave 1** |  | 924d | 2022-10-31 | 2026-05-14 |  | 2022-10-31 | 2026-05-14 | 0d | 420d |  |  | 5.31 | -650.67 | Overdue Start | RED |  |
| 2430 | 1.9.2.3.1 | **SIT Non-MVC Service Activation Preparation Tasks** |  | 924d | 2022-10-31 | 2026-05-14 |  | 2022-10-31 | 2026-05-14 | 0d | 420d |  |  | 5.31 | -651.67 | Overdue Start | RED |  |
| 2431 | 1.9.2.3.1.1 | Helix Preparatory Activities Complete | milestone | 0d | 2022-10-31 | 2022-10-31 |  | 2022-10-31 | 2022-10-31 | 0d | 1344d |  |  | 5.29 | -717.67 | Overdue Start | RED |  |
| 2432 | 1.9.2.3.1.2 | MHHSP Confirms Wave 1 PPs MHHS Enabled |  | 1d | 2022-10-31 | 2022-10-31 |  | 2022-10-31 | 2022-10-31 | 0d | 904d | 899d |  | 5.28 | -717.67 | Overdue Start | RED |  |
| 2433 | 1.9.2.3.1.3 | Wave 1 Service Activation |  | 24d | 2026-04-13 | 2026-05-14 | 1876, 2432 | 2026-04-13 | 2026-05-14 | 25d | 5d | 0d |  | 5.24 | 542.33 | Green | GREEN |  |
| 2434 | 1.9.2.3.2 | **Wave 1 - Service Activation Implementation** |  | 5d | 2025-09-01 | 2025-09-05 |  | 2025-09-01 | 2025-09-05 | 0d | 599d |  |  | 5.31 |  |  |  |  |
| 2435 | 1.9.2.3.2.1 | MHHSP Enabled Confirmation |  | 2d | 2025-09-01 | 2025-09-02 |  | 2025-09-01 | 2025-09-02 | 0d | 602d |  | finish no earlier than 2025-09-02 | 5.31 | 318.33 | Green | GREEN |  |
| 2436 | 1.9.2.3.2.2 | PAB Approval |  | 2d | 2025-09-01 | 2025-09-02 |  | 2025-09-01 | 2025-09-02 | 0d | 602d |  | finish no earlier than 2025-09-02 | 5.31 | 318.33 | Green | GREEN |  |
| 2437 | 1.9.2.3.2.3 | Add EDF to DIP |  | 2d | 2025-09-02 | 2025-09-03 |  | 2025-09-02 | 2025-09-03 | 0d | 601d |  | finish no earlier than 2025-09-03 | 5.31 | 319.33 | Green | GREEN |  |
| 2438 | 1.9.2.3.2.4 | DIP Promoted to Production |  | 2d | 2025-09-03 | 2025-09-04 |  | 2025-09-03 | 2025-09-04 | 0d | 600d |  | finish no earlier than 2025-09-04 | 5.31 | 320.33 | Green | GREEN |  |
| 2439 | 1.9.2.3.2.5 | Create M16 in Customer Solution |  | 2d | 2025-09-04 | 2025-09-05 |  | 2025-09-04 | 2025-09-05 | 0d | 599d |  | finish no earlier than 2025-09-05 | 5.31 | 321.33 | Green | GREEN |  |
| 2440 | 1.9.2.3.2.6 | Publish ISD |  | 2d | 2025-09-04 | 2025-09-05 |  | 2025-09-04 | 2025-09-05 | 0d | 599d |  | finish no earlier than 2025-09-05 | 5.31 | 321.33 | Green | GREEN |  |
| 2441 | 1.9.2.3.2.7 | Wave 1 - Service Activation Implementation Complete (M) | milestone | 0d | 2025-09-05 | 2025-09-05 |  | 2025-09-05 | 2025-09-05 | 0d | 599d |  | finish no earlier than 2025-09-05 | 5.31 | 322.71 | Green | GREEN |  |
| 2442 | 1.9.2.3.3 | **Wave 1 - Service Activation Implementation MDD** |  | 10d | 2025-09-04 | 2025-09-17 |  | 2025-09-04 | 2025-09-17 | 0d | 591d |  |  | 5.31 |  |  |  |  |
| 2443 | 1.9.2.3.3.1 | MDD Manual Load |  | 5d | 2025-09-04 | 2025-09-10 |  | 2025-09-04 | 2025-09-10 | 0d | 596d |  | finish no earlier than 2025-09-10 | 5.31 | 321.33 | Green | GREEN |  |
| 2444 | 1.9.2.3.3.2 | MDD Update |  | 6d | 2025-09-10 | 2025-09-17 |  | 2025-09-10 | 2025-09-17 | 0d | 591d |  | finish no earlier than 2025-09-17 | 5.31 | 327.33 | Green | GREEN |  |
| 2445 | 1.9.2.3.3.3 | Wave 1 - Service Activation Implementation MDD Complete (M) | milestone | 0d | 2025-09-17 | 2025-09-17 |  | 2025-09-17 | 2025-09-17 | 0d | 591d |  | finish no earlier than 2025-09-17 | 5.31 | 334.71 | Green | GREEN |  |

Notes:
- 2431: Action: 12/8/24: Emailed helix to clarify what needs to go in the prep section and if hypercare is required
- 2432: 8/7/24: Confirm Predecessors

| ID | WBS | Task | Type | Duration | Start | Finish | Predecessors | Baseline start | Baseline finish | Baseline duration | Total slack | Free slack | Constraint | Update Version | Task Status | Sched Status | RAG | Text3 |
| --- | --- | --- | --- | --- | --- | --- | --- | --- | --- | --- | --- | --- | --- | --- | --- | --- | --- | --- |
| 2446 | 1.9.2.3.4 | **Wave 1 - Service Activation Hypercare** |  | 754d | 2022-10-31 | 2025-09-18 |  | 2022-10-31 | 2025-09-18 | 0d | 590d |  |  | 5.31 |  |  |  |  |
| 2447 | 1.9.2.3.4.1 | Service& Process Monitoring |  | 14d | 2025-09-01 | 2025-09-18 |  | 2025-09-01 | 2025-09-18 | 0d | 590d |  | finish no earlier than 2025-09-18 | 5.31 | 318.33 | Green | GREEN |  |
| 2448 | 1.9.2.3.4.2 | Daily Reporting |  | 14d | 2025-09-01 | 2025-09-18 |  | 2025-09-01 | 2025-09-18 | 0d | 590d |  | finish no earlier than 2025-09-18 | 5.31 | 318.33 | Green | GREEN |  |
| 2449 | 1.9.2.3.4.3 | Issue Management |  | 14d | 2025-09-01 | 2025-09-18 |  | 2025-09-01 | 2025-09-18 | 0d | 590d |  | finish no earlier than 2025-09-18 | 5.31 | 318.33 | Green | GREEN |  |
| 2450 | 1.9.2.3.4.4 | SA Hypercare Close Down Activities |  | 14d | 2025-09-01 | 2025-09-18 |  | 2025-09-01 | 2025-09-18 | 0d | 590d |  | finish no earlier than 2025-09-18 | 5.31 | 318.33 | Green | GREEN |  |
| 2451 | 1.9.2.3.4.5 | Handover to MHHSP |  | 4d | 2025-09-15 | 2025-09-18 |  | 2025-09-15 | 2025-09-18 | 0d | 590d |  | finish no earlier than 2025-09-18 | 5.31 | 332.33 | Green | GREEN |  |
| 2452 | 1.9.2.3.4.6 | Non-SIT LDSO Service Activation Hypercare Complete (M) | milestone | 0d | 2022-10-31 | 2022-10-31 |  | 2022-10-31 | 2022-10-31 | 0d | 1344d |  |  | 5.31 | -717.67 | Overdue Start | RED | Dates to be confirmed |
| 2453 | 1.9.2.4 | **Wave 2** |  | 957d | 2022-10-31 | 2026-06-30 |  | 2022-10-31 | 2026-06-30 | 0d | 387d |  |  | 5.31 | -650.67 | Overdue Start | RED |  |
| 2454 | 1.9.2.4.1 | **SIT Non-MVC Service Activation Preparation Tasks** |  | 957d | 2022-10-31 | 2026-06-30 |  | 2022-10-31 | 2026-06-30 | 0d | 387d |  |  | 5.31 | -651.67 | Overdue Start | RED |  |
| 2455 | 1.9.2.4.1.1 | Helix Preparatory Activities Complete | milestone | 0d | 2022-10-31 | 2022-10-31 |  | 2022-10-31 | 2022-10-31 | 0d | 1344d |  |  | 5.29 | -717.67 | Overdue Start | RED |  |
| 2456 | 1.9.2.4.1.2 | MHHSP Confirms Wave 2 PPs MHHS Enabled |  | 1d | 2022-10-31 | 2022-10-31 |  | 2022-10-31 | 2022-10-31 | 0d | 938d | 932d |  | 5.28 | -717.67 | Overdue Start | RED |  |
| 2457 | 1.9.2.4.1.3 | Wave 2 Service Activation |  | 24d | 2026-05-28 | 2026-06-30 | 1906, 2456 | 2026-05-28 | 2026-06-30 | 25d | 6d | 0d |  | 5.24 | 587.33 | Green | GREEN |  |
| 2458 | 1.9.2.4.2 | **Wave 2 - Service Activation Implementation** |  | 5d | 2025-11-03 | 2025-11-07 |  | 2025-11-03 | 2025-11-07 | 0d | 554d |  |  | 5.31 |  |  |  |  |
| 2459 | 1.9.2.4.2.1 | MHHSP Enabled Confirmation |  | 2d | 2025-11-03 | 2025-11-04 |  | 2025-11-03 | 2025-11-04 | 0d | 557d |  | finish no earlier than 2025-11-04 | 5.31 | 381.33 | Green | GREEN |  |
| 2460 | 1.9.2.4.2.2 | PAB Approval |  | 2d | 2025-11-03 | 2025-11-04 |  | 2025-11-03 | 2025-11-04 | 0d | 557d |  | finish no earlier than 2025-11-04 | 5.31 | 381.33 | Green | GREEN |  |
| 2461 | 1.9.2.4.2.3 | Add EDF to DIP |  | 2d | 2025-11-04 | 2025-11-05 |  | 2025-11-04 | 2025-11-05 | 0d | 556d |  | finish no earlier than 2025-11-05 | 5.31 | 382.33 | Green | GREEN |  |
| 2462 | 1.9.2.4.2.4 | DIP Promoted to Production |  | 2d | 2025-11-05 | 2025-11-06 |  | 2025-11-05 | 2025-11-06 | 0d | 555d |  | finish no earlier than 2025-11-06 | 5.31 | 383.33 | Green | GREEN |  |
| 2463 | 1.9.2.4.2.5 | Create M16 in Customer Solution |  | 2d | 2025-11-06 | 2025-11-07 |  | 2025-11-06 | 2025-11-07 | 0d | 554d |  | finish no earlier than 2025-11-07 | 5.31 | 384.33 | Green | GREEN |  |
| 2464 | 1.9.2.4.2.6 | Publish ISD |  | 2d | 2025-11-06 | 2025-11-07 |  | 2025-11-06 | 2025-11-07 | 0d | 554d |  | finish no earlier than 2025-11-07 | 5.31 | 384.33 | Green | GREEN |  |
| 2465 | 1.9.2.4.2.7 | Wave 2 - Service Activation Implementation Complete (M) | milestone | 0d | 2025-11-07 | 2025-11-07 |  | 2025-11-07 | 2025-11-07 | 0d | 554d |  | finish no earlier than 2025-11-07 | 5.31 | 385.71 | Green | GREEN |  |
| 2466 | 1.9.2.4.3 | **Wave 2 - Service Activation Implementation MDD** |  | 10d | 2025-11-06 | 2025-11-19 |  | 2025-11-06 | 2025-11-19 | 0d | 546d |  |  | 5.31 |  |  |  |  |
| 2467 | 1.9.2.4.3.1 | MDD Manual Load |  | 5d | 2025-11-06 | 2025-11-12 |  | 2025-11-06 | 2025-11-12 | 0d | 551d |  | finish no earlier than 2025-11-12 | 5.31 | 384.33 | Green | GREEN |  |
| 2468 | 1.9.2.4.3.2 | MDD Update |  | 6d | 2025-11-12 | 2025-11-19 |  | 2025-11-12 | 2025-11-19 | 0d | 546d |  | finish no earlier than 2025-11-19 | 5.31 | 390.33 | Green | GREEN |  |
| 2469 | 1.9.2.4.3.3 | Wave 2 - Service Activation Implementation MDD Complete (M) | milestone | 0d | 2025-11-19 | 2025-11-19 |  | 2025-11-19 | 2025-11-19 | 0d | 546d |  | finish no earlier than 2025-11-19 | 5.31 | 397.71 | Green | GREEN |  |

Notes:
- 2455: Action: 12/8/24: Emailed helix to clarify what needs to go in the prep section and if hypercare is required
- 2456: 8/7/24: Confirm Predecessors

| ID | WBS | Task | Type | Duration | Start | Finish | Predecessors | Baseline start | Baseline finish | Baseline duration | Total slack | Constraint | Update Version | Task Status | Sched Status | RAG | Involved | Text3 |
| --- | --- | --- | --- | --- | --- | --- | --- | --- | --- | --- | --- | --- | --- | --- | --- | --- | --- | --- |
| 2470 | 1.9.2.4.4 | **Wave 2 - Service Activation Hypercare** |  | 14d | 2025-11-03 | 2025-11-20 |  | 2025-11-03 | 2025-11-20 | 0d | 545d |  | 5.31 |  |  |  |  |  |
| 2471 | 1.9.2.4.4.1 | Service& Process Monitoring |  | 14d | 2025-11-03 | 2025-11-20 |  | 2025-11-03 | 2025-11-20 | 0d | 545d | finish no earlier than 2025-11-20 | 5.31 | 381.33 | Green | GREEN |  |  |
| 2472 | 1.9.2.4.4.2 | Daily Reporting |  | 14d | 2025-11-03 | 2025-11-20 |  | 2025-11-03 | 2025-11-20 | 0d | 545d | finish no earlier than 2025-11-20 | 5.31 | 381.33 | Green | GREEN |  |  |
| 2473 | 1.9.2.4.4.3 | Issue Management |  | 14d | 2025-11-03 | 2025-11-20 |  | 2025-11-03 | 2025-11-20 | 0d | 545d | finish no earlier than 2025-11-20 | 5.31 | 381.33 | Green | GREEN |  |  |
| 2474 | 1.9.2.4.4.4 | SA Hypercare Close Down Activities |  | 14d | 2025-11-03 | 2025-11-20 |  | 2025-11-03 | 2025-11-20 | 0d | 545d | finish no earlier than 2025-11-20 | 5.31 | 381.33 | Green | GREEN |  |  |
| 2475 | 1.9.2.4.4.5 | Handover to MHHSP |  | 4d | 2025-11-17 | 2025-11-20 |  | 2025-11-17 | 2025-11-20 | 0d | 545d | finish no earlier than 2025-11-20 | 5.31 | 395.33 | Green | GREEN | MHHSP |  |
| 2476 | 1.9.2.4.4.6 | Wave 2 - Service Activation Hypercare Complete (M) | milestone | 0d | 2025-11-19 | 2025-11-19 |  | 2025-11-19 | 2025-11-19 | 0d | 546d | finish no earlier than 2025-11-19 | 5.31 | 397.71 | Green | GREEN |  |  |
| 2477 | 1.9.2.5 | **Wave 3** |  | 998d | 2022-10-31 | 2026-08-26 |  | 2022-10-31 | 2026-08-26 | 0d | 346d |  | 5.31 | -650.67 | Overdue Start | RED |  |  |
| 2478 | 1.9.2.5.1 | **SIT Non-MVC Service Activation Preparation Tasks** |  | 998d | 2022-10-31 | 2026-08-26 |  | 2022-10-31 | 2026-08-26 | 0d | 346d |  | 5.31 | -651.67 | Overdue Start | RED |  |  |
| 2479 | 1.9.2.5.1.1 | Helix Preparatory Activities Complete | milestone | 0d | 2022-10-31 | 2022-10-31 |  | 2022-10-31 | 2022-10-31 | 0d | 1344d |  | 5.29 | -717.67 | Overdue Start | RED |  |  |
| 2480 | 1.9.2.5.1.2 | MHHSP Confirms Wave 3 PPs MHHS Enabled |  | 1d | 2022-10-31 | 2022-10-31 |  | 2022-10-31 | 2022-10-31 | 0d | 973d |  | 5.28 | -717.67 | Overdue Start | RED |  |  |
| 2481 | 1.9.2.5.1.3 | Wave 3 Service Activation |  | 24d | 2026-07-24 | 2026-08-26 | 1936, 2480 | 2026-07-24 | 2026-08-26 | 25d | 0d |  | 5.24 | 644.33 | Green | GREEN |  |  |
| 2482 | 1.9.2.5.2 | **Wave 3 - Service Activation Implementation** |  | 7d | 2025-12-22 | 2025-12-30 |  | 2025-12-22 | 2025-12-30 | 0d | 517d |  | 5.31 |  |  |  |  |  |
| 2483 | 1.9.2.5.2.1 | MHHSP Enabled Confirmation |  | 2d | 2025-12-22 | 2025-12-23 |  | 2025-12-22 | 2025-12-23 | 0d | 522d | finish no earlier than 2025-12-23 | 5.31 | 430.33 | Green | GREEN |  |  |
| 2484 | 1.9.2.5.2.2 | PAB Approval |  | 2d | 2025-12-22 | 2025-12-23 |  | 2025-12-22 | 2025-12-23 | 0d | 522d | finish no earlier than 2025-12-23 | 5.31 | 430.33 | Green | GREEN |  |  |
| 2485 | 1.9.2.5.2.3 | Add EDF to DIP |  | 2d | 2025-12-23 | 2025-12-24 |  | 2025-12-23 | 2025-12-24 | 0d | 521d | finish no earlier than 2025-12-24 | 5.31 | 431.33 | Green | GREEN |  |  |
| 2486 | 1.9.2.5.2.4 | DIP Promoted to Production |  | 2d | 2025-12-29 | 2025-12-30 |  | 2025-12-29 | 2025-12-30 | 0d | 517d | finish no earlier than 2025-12-30 | 5.31 | 437.33 | Green | GREEN |  |  |
| 2487 | 1.9.2.5.2.5 | Create M16 in Customer Solution |  | 2d | 2025-12-29 | 2025-12-30 |  | 2025-12-29 | 2025-12-30 | 0d | 517d | finish no earlier than 2025-12-30 | 5.31 | 437.33 | Green | GREEN |  |  |
| 2488 | 1.9.2.5.2.6 | Publish ISD |  | 2d | 2025-12-29 | 2025-12-30 |  | 2025-12-29 | 2025-12-30 | 0d | 517d | finish no earlier than 2025-12-30 | 5.31 | 437.33 | Green | GREEN |  |  |
| 2489 | 1.9.2.5.2.7 | Wave 3 - Service Activation Implementation Complete (M) | milestone | 0d | 2025-12-30 | 2025-12-30 |  | 2025-12-30 | 2025-12-30 | 0d | 517d | finish no earlier than 2025-12-30 | 5.31 | 438.71 | Green | GREEN |  |  |
| 2490 | 1.9.2.5.3 | **Wave 3 - Service Activation Implementation MDD** |  | 839d | 2022-10-31 | 2026-01-15 |  | 2022-10-31 | 2026-01-15 | 0d | 505d |  | 5.31 |  |  |  |  |  |
| 2491 | 1.9.2.5.3.1 | MDD Manual Load |  | 7d | 2025-12-29 | 2026-01-06 |  | 2025-12-29 | 2026-01-06 | 0d | 512d | finish no earlier than 2026-01-06 | 5.31 | 437.33 | Green | GREEN |  |  |
| 2492 | 1.9.2.5.3.2 | MDD Update |  | 269d | 2025-01-06 | 2026-01-15 |  | 2025-01-06 | 2026-01-15 | 0d | 505d | finish no earlier than 2026-01-15 | 5.31 | 80.33 | Green | GREEN |  |  |
| 2493 | 1.9.2.5.3.3 | Wave 3 - Service Activation Implementation MDD Complete (M) | milestone | 0d | 2022-10-31 | 2022-10-31 |  | 2022-10-31 | 2022-10-31 | 0d | 1344d |  | 5.31 | -717.67 | Overdue Start | RED |  | Dates to be confirmed |

Notes:
- 2479: Action: 12/8/24: Emailed helix to clarify what needs to go in the prep section and if hypercare is required
- 2480: 8/7/24: Confirm Predecessors

| ID | WBS | Task | Type | Duration | Start | Finish | Predecessors | Baseline start | Baseline finish | Baseline duration | Total slack | Free slack | Constraint | Update Version | Task Status | Sched Status | RAG | Involved | Text3 |
| --- | --- | --- | --- | --- | --- | --- | --- | --- | --- | --- | --- | --- | --- | --- | --- | --- | --- | --- | --- |
| 2494 | 1.9.2.5.4 | **Wave 3 - Service Activation Hypercare** |  | 840d | 2022-10-31 | 2026-01-16 |  | 2022-10-31 | 2026-01-16 | 0d | 504d |  |  | 5.31 |  |  |  |  |  |
| 2495 | 1.9.2.5.4.1 | Service& Process Monitoring |  | 20d | 2025-12-22 | 2026-01-16 |  | 2025-12-22 | 2026-01-16 | 0d | 504d |  | finish no earlier than 2026-01-16 | 5.31 | 430.33 | Green | GREEN |  |  |
| 2496 | 1.9.2.5.4.2 | Daily Reporting |  | 20d | 2025-12-22 | 2026-01-16 |  | 2025-12-22 | 2026-01-16 | 0d | 504d |  | finish no earlier than 2026-01-16 | 5.31 | 430.33 | Green | GREEN |  |  |
| 2497 | 1.9.2.5.4.3 | Issue Management |  | 20d | 2025-12-22 | 2026-01-16 |  | 2025-12-22 | 2026-01-16 | 0d | 504d |  | finish no earlier than 2026-01-16 | 5.31 | 430.33 | Green | GREEN |  |  |
| 2498 | 1.9.2.5.4.4 | SA Hypercare Close Down Activities |  | 20d | 2025-12-22 | 2026-01-16 |  | 2025-12-22 | 2026-01-16 | 0d | 504d |  | finish no earlier than 2026-01-16 | 5.31 | 430.33 | Green | GREEN |  |  |
| 2499 | 1.9.2.5.4.5 | Handover to MHHSP |  | 4d | 2026-01-12 | 2026-01-15 |  | 2026-01-12 | 2026-01-15 | 0d | 505d |  | finish no earlier than 2026-01-15 | 5.31 | 451.33 | Green | GREEN | MHHSP |  |
| 2500 | 1.9.2.5.4.6 | Wave 3 Service Activation Hypercare Complete (M) | milestone | 0d | 2022-10-31 | 2022-10-31 |  | 2022-10-31 | 2022-10-31 | 0d | 1344d |  |  | 5.31 | -717.67 | Overdue Start | RED |  | Date to be confirmed |
| 2501 | 1.9.2.6 | **Wave 4** |  | 1039d | 2022-10-31 | 2026-10-22 |  | 2022-10-31 | 2026-10-22 | 0d | 305d |  |  | 5.31 | -650.67 | Overdue Start | RED |  |  |
| 2502 | 1.9.2.6.1 | **SIT Non-MVC Service Activation Preparation Tasks** |  | 1039d | 2022-10-31 | 2026-10-22 |  | 2022-10-31 | 2026-10-22 | 0d | 305d |  |  | 5.31 | -651.67 | Overdue Start | RED |  |  |
| 2503 | 1.9.2.6.1.1 | Helix Preparatory Activities Complete | milestone | 0d | 2022-10-31 | 2022-10-31 |  | 2022-10-31 | 2022-10-31 | 0d | 1344d |  |  | 5.29 | -717.67 | Overdue Start | RED |  |  |
| 2504 | 1.9.2.6.1.2 | MHHSP Confirms Wave 4 PPs MHHS Enabled |  | 1d | 2022-10-31 | 2022-10-31 |  | 2022-10-31 | 2022-10-31 | 0d | 1018d | 1014d |  | 5.28 | -717.67 | Overdue Start | RED |  |  |
| 2505 | 1.9.2.6.1.3 | Wave 4 Service Activation |  | 24d | 2026-09-21 | 2026-10-22 | 1966, 2504 | 2026-09-21 | 2026-10-22 | 25d | 4d | 0d |  | 5.24 | 703.33 | Green | GREEN |  |  |
| 2506 | 1.9.2.6.2 | **Wave 4 - Service Activation Implementation** |  | 265d | 2025-03-03 | 2026-03-06 |  | 2025-03-03 | 2026-03-06 | 0d | 469d |  |  | 5.31 |  |  |  |  |  |
| 2507 | 1.9.2.6.2.1 | MHHSP Enabled Confirmation |  | 2d | 2026-03-02 | 2026-03-03 |  | 2026-03-02 | 2026-03-03 | 0d | 472d |  | finish no earlier than 2026-03-03 | 5.31 | 500.33 | Green | GREEN |  |  |
| 2508 | 1.9.2.6.2.2 | PAB Approval |  | 1d | 2025-03-03 | 2025-03-03 |  | 2025-03-03 | 2025-03-03 | 0d | 733d |  | finish no earlier than 2025-03-03 | 5.31 | 136.33 | Green | GREEN |  |  |
| 2509 | 1.9.2.6.2.3 | Add EDF to DIP |  | 2d | 2026-03-03 | 2026-03-04 |  | 2026-03-03 | 2026-03-04 | 0d | 471d |  | finish no earlier than 2026-03-04 | 5.31 | 501.33 | Green | GREEN |  |  |
| 2510 | 1.9.2.6.2.4 | DIP Promoted to Production |  | 2d | 2026-03-04 | 2026-03-05 |  | 2026-03-04 | 2026-03-05 | 0d | 470d |  | finish no earlier than 2026-03-05 | 5.31 | 502.33 | Green | GREEN |  |  |
| 2511 | 1.9.2.6.2.5 | Create M16 in Customer Solution |  | 2d | 2026-03-05 | 2026-03-06 |  | 2026-03-05 | 2026-03-06 | 0d | 469d |  | finish no earlier than 2026-03-06 | 5.31 | 503.33 | Green | GREEN |  |  |
| 2512 | 1.9.2.6.2.6 | Publish ISD |  | 2d | 2026-03-05 | 2026-03-06 |  | 2026-03-05 | 2026-03-06 | 0d | 469d |  | finish no earlier than 2026-03-06 | 5.31 | 503.33 | Green | GREEN |  |  |
| 2513 | 1.9.2.6.2.7 | Wave 4 - Service Activation Implementation Complete (M) | milestone | 0d | 2026-03-06 | 2026-03-06 |  | 2026-03-06 | 2026-03-06 | 0d | 469d |  | finish no earlier than 2026-03-06 | 5.31 | 504.71 | Green | GREEN |  |  |
| 2514 | 1.9.2.6.3 | **Wave 4 - Service Activation Implementation MDD** |  | 15d | 2026-03-06 | 2026-03-26 |  | 2026-03-06 | 2026-03-26 | 0d | 455d |  |  | 5.31 |  |  |  |  |  |
| 2515 | 1.9.2.6.3.1 | MDD Manual Load |  | 7d | 2026-03-06 | 2026-03-16 |  | 2026-03-06 | 2026-03-16 | 0d | 463d |  | finish no earlier than 2026-03-16 | 5.31 | 504.33 | Green | GREEN |  |  |
| 2516 | 1.9.2.6.3.2 | MDD Update |  | 9d | 2026-03-16 | 2026-03-26 |  | 2026-03-16 | 2026-03-26 | 0d | 455d |  | finish no earlier than 2026-03-26 | 5.31 | 514.33 | Green | GREEN |  |  |
| 2517 | 1.9.2.6.3.3 | Wave 4 - Service Activation Implementation MDD Complete | milestone | 0d | 2026-03-25 | 2026-03-25 |  | 2026-03-25 | 2026-03-25 | 0d | 456d |  | finish no earlier than 2026-03-25 | 5.31 | 523.71 | Green | GREEN |  |  |

Notes:
- 2503: Action: 12/8/24: Emailed helix to clarify what needs to go in the prep section and if hypercare is required
- 2504: 8/7/24: Confirm Predecessors

| ID | WBS | Task | Type | Duration | Start | Finish | Predecessors | Baseline start | Baseline finish | Baseline duration | Total slack | Free slack | Constraint | Update Version | Task Status | Sched Status | RAG | Involved | Responsible |
| --- | --- | --- | --- | --- | --- | --- | --- | --- | --- | --- | --- | --- | --- | --- | --- | --- | --- | --- | --- |
| 2518 | 1.9.2.6.4 | **Wave 4 - Service Activation Hypercare** |  | 19d | 2026-03-02 | 2026-03-26 |  | 2026-03-02 | 2026-03-26 | 0d | 455d |  |  | 5.31 |  |  |  |  |  |
| 2519 | 1.9.2.6.4.1 | Service& Process Monitoring |  | 19d | 2026-03-02 | 2026-03-26 |  | 2026-03-02 | 2026-03-26 | 0d | 455d |  | finish no earlier than 2026-03-26 | 5.31 | 500.33 | Green | GREEN |  |  |
| 2520 | 1.9.2.6.4.2 | Daily Reporting |  | 19d | 2026-03-02 | 2026-03-26 |  | 2026-03-02 | 2026-03-26 | 0d | 455d |  | finish no earlier than 2026-03-26 | 5.31 | 500.33 | Green | GREEN |  |  |
| 2521 | 1.9.2.6.4.3 | Issue Management |  | 19d | 2026-03-02 | 2026-03-26 |  | 2026-03-02 | 2026-03-26 | 0d | 455d |  | finish no earlier than 2026-03-26 | 5.31 | 500.33 | Green | GREEN |  |  |
| 2522 | 1.9.2.6.4.4 | SA Hypercare Close Down Activities |  | 19d | 2026-03-02 | 2026-03-26 |  | 2026-03-02 | 2026-03-26 | 0d | 455d |  | finish no earlier than 2026-03-26 | 5.31 | 500.33 | Green | GREEN |  |  |
| 2523 | 1.9.2.6.4.5 | Handover to MHHSP |  | 4d | 2026-03-02 | 2026-03-05 |  | 2026-03-02 | 2026-03-05 | 0d | 470d |  | finish no earlier than 2026-03-05 | 5.31 | 500.33 | Green | GREEN | MHHSP |  |
| 2524 | 1.9.2.6.4.6 | Wave 4 - Service Activation Hypercare Complete (M) | milestone | 0d | 2026-03-25 | 2026-03-25 |  | 2026-03-25 | 2026-03-25 | 0d | 456d |  | finish no earlier than 2026-03-25 | 5.31 | 523.71 | Green | GREEN |  |  |
| 2525 | 1.9.2.7 | **Non-SIT LDSO** |  | 741d | 2022-10-31 | 2025-09-01 |  | 2022-10-31 | 2025-09-01 | 0d | 603d |  |  | 5.31 | -650.67 | Overdue Start | RED |  |  |
| 2526 | 1.9.2.7.1 | **Non-SIT LDSO Service Activation Data Loading** |  | 176d | 2024-06-07 | 2025-02-07 |  | 2024-06-07 | 2025-02-07 | 0d | 749d |  |  | 5.31 |  |  |  |  |  |
| 2527 | 1.9.2.7.1.1 | Define pre Non-SIT LDSO upfront activities |  | 7d | 2024-06-07 | 2024-06-17 |  | 2024-06-07 | 2024-06-17 | 0d | 918d |  | finish no earlier than 2024-06-17 | 5.31 | -132.67 | Overdue Start | RED |  |  |
| 2528 | 1.9.2.7.1.2 | **Execute Non-SIT LDSO Activities** |  | 5d | 2025-02-03 | 2025-02-07 |  | 2025-02-03 | 2025-02-07 | 0d | 749d |  |  | 5.31 |  |  |  |  |  |
| 2529 | 1.9.2.7.1.2.1 | Create Entity Forms in Customer Solution |  | 3d | 2025-02-03 | 2025-02-05 |  | 2025-02-03 | 2025-02-05 | 0d | 751d |  | finish no earlier than 2025-02-05 | 5.31 | 108.33 | Green | GREEN |  | PMP |
| 2530 | 1.9.2.7.1.2.2 | DIP - Promote to Production Environment |  | 3d | 2025-02-03 | 2025-02-05 |  | 2025-02-03 | 2025-02-05 | 0d | 751d |  | finish no earlier than 2025-02-05 | 5.31 | 108.33 | Green | GREEN |  | DIP |
| 2531 | 1.9.2.7.1.2.3 | DIP - Enable Technology capabilities for participants |  | 3d | 2025-02-03 | 2025-02-05 |  | 2025-02-03 | 2025-02-05 | 0d | 751d |  | finish no earlier than 2025-02-05 | 5.31 | 108.33 | Green | GREEN |  | DIP |
| 2532 | 1.9.2.7.1.2.4 | DIP - Add EFD to DIP |  | 3d | 2025-02-03 | 2025-02-05 |  | 2025-02-03 | 2025-02-05 | 0d | 751d |  | finish no earlier than 2025-02-05 | 5.31 | 108.33 | Green | GREEN |  | DIP |
| 2533 | 1.9.2.7.1.2.5 | ISD - Replicate Entity Forms from CS |  | 2d | 2025-02-06 | 2025-02-07 |  | 2025-02-06 | 2025-02-07 | 0d | 749d |  | finish no earlier than 2025-02-07 | 5.31 | 111.33 | Green | GREEN |  | HELIX |
| 2534 | 1.9.2.7.1.2.6 | MDD - Load MHHS roles |  | 3d | 2025-02-03 | 2025-02-05 |  | 2025-02-03 | 2025-02-05 | 0d | 751d |  | finish no earlier than 2025-02-05 | 5.31 | 108.33 | Green | GREEN |  | PMP |
| 2535 | 1.9.2.7.1.3 | Non-SIT LDSO Service Activation Data Loading Completed (M) | milestone | 0d | 2025-02-07 | 2025-02-07 |  | 2025-02-07 | 2025-02-07 | 0d | 749d |  | finish no earlier than 2025-02-07 | 5.31 | 112.71 | Green | GREEN |  |  |
| 2536 | 1.9.2.7.2 | **SIT Non-MVC Service Activation Preparation Tasks** |  | 741d | 2022-10-31 | 2025-09-01 |  | 2022-10-31 | 2025-09-01 | 0d | 603d |  |  | 5.31 | -651.67 | Overdue Start | RED |  |  |
| 2537 | 1.9.2.7.2.1 | Helix Preparatory Activities Complete | milestone | 0d | 2022-10-31 | 2022-10-31 |  | 2022-10-31 | 2022-10-31 | 0d | 1344d |  |  | 5.29 | -717.67 | Overdue Start | RED |  |  |
| 2538 | 1.9.2.7.2.2 | MHHSP Confirms Non-SIT LDSO PPs MHHS Enabled |  | 1d | 2022-10-31 | 2022-10-31 |  | 2022-10-31 | 2022-10-31 | 0d | 756d | 734d |  | 5.28 | -717.67 | Overdue Start | RED |  |  |
| 2539 | 1.9.2.7.2.3 | Non-SIT LDSO Service Activation |  | 6d | 2025-08-25 | 2025-09-01 | 1614, 2538 | 2025-08-25 | 2025-09-01 | 9d | 22d | 17d |  | 5.24 | 311.33 | Green | GREEN |  |  |
| 2540 | 1.9.2.7.3 | **Non-SIT LDSO Service Activation Implementation** |  | 4d | 2025-02-24 | 2025-02-27 |  | 2025-02-24 | 2025-02-27 | 0d | 735d |  |  | 5.31 |  |  |  |  |  |
| 2541 | 1.9.2.7.3.1 | MHHSP Enabled Confirmation |  | 2d | 2025-02-24 | 2025-02-25 |  | 2025-02-24 | 2025-02-25 | 0d | 737d |  | finish no earlier than 2025-02-25 | 5.31 | 129.33 | Green | GREEN |  | MHHSP |
| 2542 | 1.9.2.7.3.2 | PAB Approval |  | 2d | 2025-02-24 | 2025-02-25 |  | 2025-02-24 | 2025-02-25 | 0d | 737d |  | finish no earlier than 2025-02-25 | 5.31 | 129.33 | Green | GREEN |  | QUALF |
| 2543 | 1.9.2.7.3.3 | Add EDF to DIP |  | 2d | 2025-02-25 | 2025-02-26 |  | 2025-02-25 | 2025-02-26 | 0d | 736d |  | finish no earlier than 2025-02-26 | 5.31 | 130.33 | Green | GREEN |  | DIP |
| 2544 | 1.9.2.7.3.4 | DIP Promoted to Production |  | 2d | 2025-02-26 | 2025-02-27 |  | 2025-02-26 | 2025-02-27 | 0d | 735d |  | finish no earlier than 2025-02-27 | 5.31 | 131.33 | Green | GREEN |  | DIP |
| 2545 | 1.9.2.7.3.5 | Create M16 in Customer Solution |  | 2d | 2025-02-26 | 2025-02-27 |  | 2025-02-26 | 2025-02-27 | 0d | 735d |  | finish no earlier than 2025-02-27 | 5.31 | 131.33 | Green | GREEN |  | PMP |
| 2546 | 1.9.2.7.3.6 | Publish ISD |  | 2d | 2025-02-26 | 2025-02-27 |  | 2025-02-26 | 2025-02-27 | 0d | 735d |  | finish no earlier than 2025-02-27 | 5.31 | 131.33 | Green | GREEN |  |  |
| 2547 | 1.9.2.7.3.7 | Non-SIT LDSO Service Activation Implementation Completed (M) | milestone | 0d | 2025-02-27 | 2025-02-27 |  | 2025-02-27 | 2025-02-27 | 0d | 735d |  | finish no earlier than 2025-02-27 | 5.31 | 132.71 | Green | GREEN |  |  |

Notes:
- 2537: Action: 12/8/24: Emailed helix to clarify what needs to go in the prep section and if hypercare is required
- 2538: 8/7/24: Confirm Predecessors

| ID | WBS | Task | Type | Duration | Start | Finish | Predecessors | Baseline start | Baseline finish | Baseline duration | Baseline 1 start | Baseline 1 finish | Total slack | Free slack | Constraint | Baseline cost | Update Version | Responsible | Task Status | Sched Status | RAG | Involved | MHHS Resource Name | MHHS Programme Phase | Artefact ID | Action |
| --- | --- | --- | --- | --- | --- | --- | --- | --- | --- | --- | --- | --- | --- | --- | --- | --- | --- | --- | --- | --- | --- | --- | --- | --- | --- | --- |
| 2548 | 1.9.2.7.4 | **Non-SIT LDSO Service Activation Implementation MDD** |  | 14d | 2025-02-27 | 2025-03-18 |  | 2025-02-27 | 2025-03-18 | 0d |  |  | 722d |  |  |  | 5.31 |  |  |  |  |  |  |  |  |  |
| 2549 | 1.9.2.7.4.1 | MDD Manual Load |  | 7d | 2025-02-27 | 2025-03-07 |  | 2025-02-27 | 2025-03-07 | 0d |  |  | 729d |  | finish no earlier than 2025-03-07 |  | 5.31 | PMP | 132.33 | Green | GREEN |  |  |  |  |  |
| 2550 | 1.9.2.7.4.2 | MDD Update |  | 8d | 2025-03-07 | 2025-03-18 |  | 2025-03-07 | 2025-03-18 | 0d |  |  | 722d |  | finish no earlier than 2025-03-18 |  | 5.31 | PMP | 140.33 | Green | GREEN |  |  |  |  |  |
| 2551 | 1.9.2.7.4.3 | Non-SIT LDSO Service Activation Implementation MDD Complete (M) | milestone | 0d | 2025-03-18 | 2025-03-18 |  | 2025-03-18 | 2025-03-18 | 0d |  |  | 722d |  | finish no earlier than 2025-03-18 |  | 5.31 |  | 151.71 | Green | GREEN |  |  |  |  |  |
| 2552 | 1.9.2.7.5 | **Non-SIT LDSO Service Activation Hypercare** |  | 18d | 2025-02-24 | 2025-03-19 |  | 2025-02-24 | 2025-03-19 | 0d |  |  | 721d |  |  |  | 5.31 |  |  |  |  |  |  |  |  |  |
| 2553 | 1.9.2.7.5.1 | **Non-SIT LDSO Service Activation Hypercare Support** |  | 18d | 2025-02-24 | 2025-03-19 |  | 2025-02-24 | 2025-03-19 | 0d |  |  | 721d |  |  |  | 5.31 |  |  |  |  |  |  |  |  |  |
| 2554 | 1.9.2.7.5.1.1 | Service& Process Monitoring |  | 18d | 2025-02-24 | 2025-03-19 |  | 2025-02-24 | 2025-03-19 | 0d |  |  | 721d |  | finish no earlier than 2025-03-19 |  | 5.31 |  | 129.33 | Green | GREEN |  |  |  |  |  |
| 2555 | 1.9.2.7.5.1.2 | Daily Reporting |  | 18d | 2025-02-24 | 2025-03-19 |  | 2025-02-24 | 2025-03-19 | 0d |  |  | 721d |  | finish no earlier than 2025-03-19 |  | 5.31 |  | 129.33 | Green | GREEN |  |  |  |  |  |
| 2556 | 1.9.2.7.5.1.3 | Issue Management |  | 18d | 2025-02-24 | 2025-03-19 |  | 2025-02-24 | 2025-03-19 | 0d |  |  | 721d |  | finish no earlier than 2025-03-19 |  | 5.31 |  | 129.33 | Green | GREEN |  |  |  |  |  |
| 2557 | 1.9.2.7.5.1.4 | SA Hypercare Close Down Activities |  | 18d | 2025-02-24 | 2025-03-19 |  | 2025-02-24 | 2025-03-19 | 0d |  |  | 721d |  | finish no earlier than 2025-03-19 |  | 5.31 |  | 129.33 | Green | GREEN |  |  |  |  |  |
| 2558 | 1.9.2.7.5.1.5 | Handover to MHHSP |  | 3d | 2025-03-14 | 2025-03-18 |  | 2025-03-14 | 2025-03-18 | 0d |  |  | 722d |  | finish no earlier than 2025-03-18 |  | 5.31 |  | 147.33 | Green | GREEN | MHHSP |  |  |  |  |
| 2559 | 1.9.2.7.5.1.6 | Non-SIT LDSO Service Activation Hypercare Complete (M) | milestone | 0d | 2025-03-18 | 2025-03-18 |  | 2025-03-18 | 2025-03-18 | 0d |  |  | 722d |  | finish no earlier than 2025-03-18 |  | 5.31 |  | 151.71 | Green | GREEN |  |  |  |  |  |
| 2560 | 1.9.3 | **Implement Early Life Support Plan** |  | 45d | 2025-01-06 | 2025-03-07 |  | 2025-01-06 | 2025-03-07 | 45d | 2025-01-06 | 2025-02-28 | 729d |  |  | -0 | 5.0 | N/A |  |  |  | N/A | N/A | Business & Operational Readiness |  |  |
| 2561 | 1.9.3.1 | Implement Early Life Support Plan |  | 45d | 2025-01-06 | 2025-03-07 | 2369 | 2025-01-06 | 2025-03-07 | 45d | 2025-02-28 | 2025-02-28 | 729d |  | start no earlier than 2025-01-06 |  | 5.23 | SI Transition | 80.33 | Green | GREEN | SI Transition,CPT | Matthew Breen | Business & Operational Readiness | MHHS-ART095 |  |
| 2562 | 1.9.4 | **Business Continuity and Disaster Recovery Plan** |  | 40d | 2025-07-31 | 2025-09-24 |  | 2025-07-31 | 2025-09-24 | 40d | 2025-01-13 | 2025-03-07 | 586d |  |  |  | 5.0 | N/A |  |  |  | N/A | N/A | Business & Operational Readiness |  |  |
| 2563 | 1.9.4.1 | Central Parties BCDRs in Place |  | 20d | 2025-07-31 | 2025-08-27 | 2103FS-40d | 2025-07-31 | 2025-08-27 | 20d | 2025-01-13 | 2025-02-07 | 586d | 0d |  |  | 5.0 | SI Design | 286.33 | Green | GREEN |  | MHHS Programme | Business & Operational Readiness |  |  |
| 2564 | 1.9.4.2 | Risk Based Assurance of Cental Party BCDRs |  | 20d | 2025-08-28 | 2025-09-24 | 2563 | 2025-08-28 | 2025-09-24 | 20d | 2025-02-10 | 2025-03-07 | 586d |  |  |  | 5.0 | PP | 314.33 | Green | GREEN | SI Design | MHHS Programme | Business & Operational Readiness |  |  |
| 2565 | 1.9.5 | **Training and Support Materials** |  | 39d | 2025-08-21 | 2025-10-14 |  | 2025-08-21 | 2025-10-14 | 40d | 2025-02-03 | 2025-03-28 | 572d |  |  |  | 5.0 | N/A |  |  |  | N/A | N/A | Business & Operational Readiness |  | 10/5: To be reworked with better clarity (LH) |
| 2566 | 1.9.5.1 | Develop document |  | 20d | 2025-08-21 | 2025-09-17 | 2354FS-45d | 2025-08-21 | 2025-09-17 | 20d | 2025-02-03 | 2025-02-28 | 572d | 0d |  |  | 5.0 | SI Migration | 307.33 | Green | GREEN | CPT | PPC | Business & Operational Readiness |  |  |
| 2567 | 1.9.5.2 | Document review and update |  | 19d | 2025-09-18 | 2025-10-14 | 2566 | 2025-09-18 | 2025-10-14 | 20d | 2025-03-03 | 2025-03-28 | 572d | 0d |  |  | 5.0 | SI Migration | 335.33 | Green | GREEN | PMO,CPT,IPA,PP | PPC | Business & Operational Readiness |  |  |
| 2568 | 1.9.5.3 | Training and Support Materials approved | milestone | 0d | 2025-10-14 | 2025-10-14 | 2567 | 2025-10-14 | 2025-10-14 | 0d | 2025-03-28 | 2025-03-28 | 572d |  |  |  | 5.0 | SI Migration | 361.71 | Green | GREEN | PMO,CPT | PPC | Business & Operational Readiness | MHHS-ART118 |  |
| 2569 | 1.9.6 | **PP Business Change** |  | 129d | 2025-02-03 | 2025-07-31 |  | 2025-02-03 | 2025-07-31 | 129d | 2025-02-03 | 2025-07-31 | 625d |  |  |  | 5.0 | N/A | M11 |  |  | N/A | N/A | Business & Operational Readiness |  | 10/5: Review with PPC (LH) |
| 2570 | 1.9.6.1 | Plan stakeholder management |  | 129d | 2025-02-03 | 2025-07-31 |  | 2025-02-03 | 2025-07-31 | 129d | 2025-02-03 | 2025-07-31 | 625d |  | start no earlier than 2025-02-03 |  | 5.0 | PP | 108.33 | Green | GREEN | PPC | PPC | Business & Operational Readiness |  |  |
| 2571 | 1.9.6.2 | Manage stakeholders |  | 129d | 2025-02-03 | 2025-07-31 |  | 2025-02-03 | 2025-07-31 | 129d | 2025-02-03 | 2025-07-31 | 625d |  | start no earlier than 2025-02-03 |  | 5.0 | PP | 108.33 | Green | GREEN | PPC | PPC | Business & Operational Readiness |  |  |
| 2572 | 1.9.6.3 | Develop & implement changes to KPIs, organisation & people management |  | 129d | 2025-02-03 | 2025-07-31 |  | 2025-02-03 | 2025-07-31 | 129d | 2025-02-03 | 2025-07-31 | 625d |  | start no earlier than 2025-02-03 |  | 5.0 | PP | 108.33 | Green | GREEN | PPC | PPC | Business & Operational Readiness |  |  |
| 2573 | 1.9.6.4 | Develop & test changes to business processes |  | 129d | 2025-02-03 | 2025-07-31 |  | 2025-02-03 | 2025-07-31 | 129d | 2025-02-03 | 2025-07-31 | 625d |  | start no earlier than 2025-02-03 |  | 5.0 | PP | 108.33 | Green | GREEN | PPC | PPC | Business & Operational Readiness |  |  |
| 2574 | 1.9.6.5 | Develop and deliver training |  | 129d | 2025-02-03 | 2025-07-31 |  | 2025-02-03 | 2025-07-31 | 129d | 2025-02-03 | 2025-07-31 | 625d |  | start no earlier than 2025-02-03 |  | 5.0 | PP | 108.33 | Green | GREEN | PPC | PPC | Business & Operational Readiness |  |  |
| 2575 | 1.9.6.6 | Programme support for PP Business Change activities |  | 129d | 2025-02-03 | 2025-07-31 |  | 2025-02-03 | 2025-07-31 | 129d | 2025-02-03 | 2025-07-31 | 625d |  | start no earlier than 2025-02-03 |  | 5.0 | PPC | 108.33 | Green | GREEN | PP | PPC | Business & Operational Readiness |  |  |

| ID | WBS | Task | Type | Duration | Start | Finish | Predecessors | Baseline start | Baseline finish | Baseline duration | Baseline 1 start | Baseline 1 finish | Total slack | Free slack | Baseline cost | Responsible | Involved | Task Status | Update Version | MHHS Resource Name | MHHS Programme Phase | Sched Status | RAG | Milestone ID | Text29 | Tier | Text3 | Artefact ID |
| --- | --- | --- | --- | --- | --- | --- | --- | --- | --- | --- | --- | --- | --- | --- | --- | --- | --- | --- | --- | --- | --- | --- | --- | --- | --- | --- | --- | --- |
| 2576 | 1.9.7 | **Transition to New Settlement Timetable (M16)** |  | 566d | 2025-10-22 | 2027-12-23 |  | 2025-10-22 | 2027-12-23 | 560d |  |  | 0d |  | -0 | N/A | N/A | -434.67 | 5.15 | N/A | Business & Operational Readiness |  |  |  |  |  |  |  |
| 2577 | 1.9.7.1 | Elexon to produce Settlement Calendar for Settlement Year 2025/2026 | milestone | 0d | 2025-10-22 | 2025-10-22 | 2352 | 2025-10-22 | 2025-10-22 | 0d |  |  | 5d | 0d |  | PP | PP, Code Bodies | 369.71 | 5.15 | Matthew Breen | Business & Operational Readiness | Green | GREEN |  |  |  |  |  |
| 2578 | 1.9.7.2 | Elexon monitor settlement data of migrated MPANs |  | 436d | 2025-10-23 | 2027-06-24 | 2577 | 2025-10-23 | 2027-06-24 | 436d |  |  | 6d |  |  | PP | PP, Code Bodies | 370.33 | 5.15 | Matthew Breen | Business & Operational Readiness | Green | GREEN |  |  |  |  |  |
| 2579 | 1.9.7.3 | M16 Checkpoint 1 | milestone | 0d | 2026-06-25 | 2026-06-25 | 2577FS+176d | 2026-06-25 | 2026-06-25 | 0d |  |  | 5d | 0d |  | PP | PP, Code Bodies | 615.71 | 5.15 | Matthew Breen | Business & Operational Readiness | Green | GREEN |  |  |  |  |  |
| 2580 | 1.9.7.4 | Confirm if M16 date retained as 07/12/2026 | milestone | 0d | 2026-07-23 | 2026-07-23 | 2579FS+20d | 2026-07-23 | 2026-07-23 | 0d |  |  | 5d | 0d |  | CPT | PP | 643.71 | 5.15 | Matthew Breen | Business & Operational Readiness | Green | GREEN |  |  |  |  |  |
| 2581 | 1.9.7.5 | Readiness assessment of participants' readiness to transition to new Settlement Timetable | milestone | 0d | 2026-08-20 | 2026-08-20 | 2580FS+20d | 2026-08-20 | 2026-08-20 | 0d |  |  | 5d | 0d |  | CPT | PP | 671.71 | 5.15 | Matthew Breen | Business & Operational Readiness | Green | GREEN |  |  |  |  |  |
| 2582 | 1.9.7.6 | Elexon to produce Settlement Calendar for Settlement Year 2026 up until day before M16 cutover | milestone | 0d | 2026-10-19 | 2026-10-19 | 2581FS+42d | 2026-10-19 | 2026-10-19 | 0d |  |  | 5d | 0d |  | PP | PP, Code Bodies | 731.71 | 5.15 | Matthew Breen | Business & Operational Readiness | Green | GREEN |  |  |  |  |  |
| 2583 | 1.9.7.7 | M16 Checkpoint 2 | milestone | 0d | 2027-04-02 | 2027-04-02 | 2582FS+119d | 2027-04-02 | 2027-04-02 | 0d |  |  | 5d | 0d |  | PP | PP, Code Bodies | 896.71 | 5.15 | Matthew Breen | Business & Operational Readiness | Green | GREEN |  |  |  |  |  |
| 2584 | 1.9.7.8 | Readiness assessment of participants' readiness to transition to new Settlement Timetable | milestone | 0d | 2027-04-19 | 2027-04-19 | 2583FS+11d | 2027-04-19 | 2027-04-19 | 0d |  |  | 5d | 0d |  | CPT | PP | 913.71 | 5.15 | Matthew Breen | Business & Operational Readiness | Green | GREEN |  |  |  |  |  |
| 2585 | 1.9.7.9 | Confirm M16 Date | milestone | 0d | 2027-04-30 | 2027-04-30 | 2584FS+9d | 2027-04-30 | 2027-04-30 | 1d |  |  | 5d | 0d |  | CPT | Code Bodies,CPT,PP,SRO | 924.71 | 5.3 | Matthew Breen | Business & Operational Readiness | Green | GREEN | T2-EL-0100 | PSG/BSC PAB | T2 |  |  |
| 2586 | 1.9.7.10 | Raise fast track change to ISD (November publish) | milestone | 0d | 2027-04-30 | 2027-04-30 | 2585 | 2027-04-30 | 2027-04-30 | 0d |  |  | 45d |  |  | PP | PP,CPT,Code Bodies | 924.71 | 5.15 | Matthew Breen | Business & Operational Readiness | Green | GREEN |  |  |  |  |  |
| 2587 | 1.9.7.11 | **M16 Approval Window** |  | 129d | 2027-06-25 | 2027-12-23 |  | 2027-06-25 | 2027-12-23 | 124d | 2026-12-07 | 2027-05-24 | 0d |  |  | N/A | N/A | 966.71 | 5.0 | N/A | Business & Operational Readiness | Green | GREEN |  |  |  |  |  |
| 2588 | 1.9.7.11.1 | Panel approval that M16 criteria met | milestone | 0d | 2027-06-25 | 2027-06-25 | 2585FS+40d | 2027-06-25 | 2027-06-25 | 0d | 2026-12-07 | 2026-12-07 | 5d |  |  | Panel | Code Bodies,CPT,PP,SRO | 980.71 | 5.0 | Matthew Breen | Business & Operational Readiness | Green | GREEN |  |  |  |  |  |
| 2589 | 1.9.7.11.2 | Cut over to new settlement timetable (M16) | milestone | 0d | 2027-07-02 | 2027-07-02 | 2588, 2356FS+40d, 2578, 2586, 2266 | 2027-07-02 | 2027-07-02 | 0d | 2026-12-07 | 2026-12-07 | 0d |  |  | CPT | PP | 987.71 | 5.0 | Matthew Breen | Business & Operational Readiness | Green | GREEN | T1-EL-1000 | PSG | T1 |  |  |
| 2590 | 1.9.7.11.3 | Maximum 6-month window for approval of M16 |  | 124d | 2027-07-05 | 2027-12-23 | 2589 | 2027-07-05 | 2027-12-23 | 124d | 2026-12-08 | 2027-05-24 | 0d |  |  | CPT |  | 990.33 | 5.0 | Matthew Breen | Business & Operational Readiness | Green | GREEN |  |  |  |  |  |
| 2591 | 1.9.7.11.4 | Cut over to new settlement timetable (M16*) - Late Exit | milestone | 0d | 2027-12-23 | 2027-12-23 | 2590 | 2027-12-23 | 2027-12-23 | 0d | 2027-05-24 | 2027-05-24 | 0d |  |  | CPT | PP | 1161.71 | 5.0 | Matthew Breen | Business & Operational Readiness | Green | GREEN | T1-EL-2000 | PSG | T1 |  |  |
| 2592 | 1.10 | **EARLY LIVE RUNNING** |  | 45d | 2027-05-10 | 2027-07-09 |  | 2027-05-10 | 2027-07-09 | 889d | 2024-01-02 | 2027-05-28 | 119d |  |  | N/A | N/A |  |  | N/A | Early Live Running |  |  |  |  |  | 1 Nov 2025 - 30 Apr 2026 |  |
| 2593 | 1.10.1 | **Early Live Running Stabilisation Period** |  | 45d | 2027-05-10 | 2027-07-09 |  | 2027-05-10 | 2027-07-09 | 45d | 2026-10-06 | 2026-12-07 | 119d |  |  | N/A | N/A |  | 5.0 | N/A | Early Live Running |  |  |  |  |  |  |  |
| 2594 | 1.10.1.1 | Manage Early Live Running stabilisation period |  | 45d | 2027-05-10 | 2027-07-09 | 2356 | 2027-05-10 | 2027-07-09 | 45d | 2026-10-06 | 2026-12-07 | 119d | 0d |  | Code Bodies | PP | 934.33 | 5.0 | Matthew Breen | Early Live Running | Green | GREEN |  |  |  |  |  |
| 2595 | 1.10.1.2 | Monitor Early Live Running stabilisation period |  | 45d | 2027-05-10 | 2027-07-09 | 2594SS | 2027-05-10 | 2027-07-09 | 45d | 2026-10-06 | 2026-12-07 | 119d |  |  | SI Migration | Code Bodies,PP | 934.33 | 5.0 | Matthew Breen | Early Live Running | Green | GREEN |  |  |  |  |  |
| 2596 | 1.11 | **PROGRAMME CLOSURE** |  | 80d | 2027-03-08 | 2027-06-25 |  | 2027-03-08 | 2027-06-25 | 85d | 2026-08-04 | 2026-11-30 | 129d |  |  | N/A | N/A |  |  | N/A | Programme Closure |  |  |  |  |  |  |  |
| 2597 | 1.11.1 | **Handover Pack** |  | 80d | 2027-03-08 | 2027-06-25 |  | 2027-03-08 | 2027-06-25 | 85d | 2026-08-04 | 2026-11-30 | 129d |  |  | N/A | N/A |  | 5.0 | N/A | Programme Closure |  |  |  |  |  |  |  |
| 2598 | 1.11.1.1 | **Draft Handover Pack (for M15)** |  | 40d | 2027-03-08 | 2027-04-30 |  | 2027-03-08 | 2027-04-30 | 40d | 2026-08-04 | 2026-09-28 | 169d |  |  | N/A | N/A |  | 5.0 | N/A | Programme Closure |  |  |  |  |  |  |  |
| 2599 | 1.11.1.1.1 | Develop document |  | 20d | 2027-03-08 | 2027-04-02 | 2356FS-45d | 2027-03-08 | 2027-04-02 | 20d | 2026-08-04 | 2026-08-31 | 169d | 0d |  | PMO | CPT | 871.33 | 5.0 |  | Programme Closure | Green | GREEN |  |  |  |  |  |
| 2600 | 1.11.1.1.2 | Document review and update |  | 20d | 2027-04-05 | 2027-04-30 | 2599 | 2027-04-05 | 2027-04-30 | 20d | 2026-09-01 | 2026-09-28 | 169d | 0d |  | SRO | PMO,CPT,IPA,PP | 899.33 | 5.0 |  | Programme Closure | Green | GREEN |  |  |  |  |  |
| 2601 | 1.11.1.1.3 | Draft Handover Pack approved | milestone | 0d | 2027-04-30 | 2027-04-30 | 2600 | 2027-04-30 | 2027-04-30 | 0d | 2026-09-28 | 2026-09-28 | 169d |  |  | SRO | PMO,CPT | 924.71 | 5.0 |  | Programme Closure | Green | GREEN |  |  |  |  | MHHS-ART126 |

| ID | WBS | Task | Type | Duration | Start | Finish | Predecessors | Baseline start | Baseline finish | Baseline duration | Baseline 1 start | Baseline 1 finish | Total slack | Free slack | Responsible | Involved | Update Version | MHHS Resource Name | MHHS Programme Phase | Task Status | Sched Status | RAG | Artefact ID | Milestone ID | Text29 | Tier |
| --- | --- | --- | --- | --- | --- | --- | --- | --- | --- | --- | --- | --- | --- | --- | --- | --- | --- | --- | --- | --- | --- | --- | --- | --- | --- | --- |
| 2602 | 1.11.1.2 | **Master Handover Pack (for M16)** |  | 40d | 2027-05-03 | 2027-06-25 |  | 2027-05-03 | 2027-06-25 | 40d | 2026-10-06 | 2026-11-30 | 129d |  | N/A | N/A | 5.0 | N/A | Programme Closure |  |  |  |  |  |  |  |
| 2603 | 1.11.1.2.1 | Update document |  | 20d | 2027-05-03 | 2027-05-28 | 2589FS-45d | 2027-05-03 | 2027-05-28 | 20d | 2026-10-06 | 2026-11-02 | 129d | 0d | PMO | CPT | 5.0 |  | Programme Closure | 927.33 | Green | GREEN |  |  |  |  |
| 2604 | 1.11.1.2.2 | Document review and update |  | 20d | 2027-05-31 | 2027-06-25 | 2603 | 2027-05-31 | 2027-06-25 | 20d | 2026-11-03 | 2026-11-30 | 129d | 0d | SRO | PMO,CPT,IPA,PP | 5.0 |  | Programme Closure | 955.33 | Green | GREEN |  |  |  |  |
| 2605 | 1.11.1.2.3 | Master Handover Pack approved | milestone | 0d | 2027-06-25 | 2027-06-25 | 2604 | 2027-06-25 | 2027-06-25 | 0d | 2026-11-30 | 2026-11-30 | 129d |  | SRO | PMO,CPT | 5.0 |  | Programme Closure | 980.71 | Green | GREEN | MHHS-ART126 |  |  |  |
| 2606 | 1.11.2 | **Programme Lessons Learned** |  | 40d | 2027-03-08 | 2027-04-30 |  | 2027-03-08 | 2027-04-30 | 40d | 2026-08-04 | 2026-09-28 | 169d |  | N/A | N/A | 5.0 | N/A | Programme Closure |  |  |  |  |  |  |  |
| 2607 | 1.11.2.1 | Develop document |  | 20d | 2027-03-08 | 2027-04-02 | 2356FS-45d | 2027-03-08 | 2027-04-02 | 20d | 2026-08-04 | 2026-08-31 | 169d | 0d | PMO | CPT | 5.0 |  | Programme Closure | 871.33 | Green | GREEN |  |  |  |  |
| 2608 | 1.11.2.2 | Document review and update |  | 20d | 2027-04-05 | 2027-04-30 | 2607 | 2027-04-05 | 2027-04-30 | 20d | 2026-09-01 | 2026-09-28 | 169d | 0d | SRO | PMO,CPT,IPA | 5.0 |  | Programme Closure | 899.33 | Green | GREEN |  |  |  |  |
| 2609 | 1.11.2.3 | Programme Lessons Learned document approved | milestone | 0d | 2027-04-30 | 2027-04-30 | 2608 | 2027-04-30 | 2027-04-30 | 0d | 2026-09-28 | 2026-09-28 | 169d |  | SRO | PMO,CPT | 5.0 |  | Programme Closure | 924.71 | Green | GREEN | MHHS-ART131 |  |  |  |
| 2610 | 1.11.3 | **Programme Closure Report** |  | 40d | 2027-03-08 | 2027-04-30 |  | 2027-03-08 | 2027-04-30 | 40d | 2026-08-04 | 2026-09-28 | 169d |  | N/A | N/A | 5.0 | N/A | Programme Closure |  |  |  |  |  |  |  |
| 2611 | 1.11.3.1 | Develop document |  | 20d | 2027-03-08 | 2027-04-02 | 2356FS-45d | 2027-03-08 | 2027-04-02 | 20d | 2026-08-04 | 2026-08-31 | 169d | 0d | PMO | CPT | 5.0 |  | Programme Closure | 871.33 | Green | GREEN |  |  |  |  |
| 2612 | 1.11.3.2 | Document review and update |  | 20d | 2027-04-05 | 2027-04-30 | 2611 | 2027-04-05 | 2027-04-30 | 20d | 2026-09-01 | 2026-09-28 | 169d | 0d | Ofgem | PMO,CPT,IPA,SRO | 5.0 |  | Programme Closure | 899.33 | Green | GREEN |  |  |  |  |
| 2613 | 1.11.3.3 | Programme Closure Report approved | milestone | 0d | 2027-04-30 | 2027-04-30 | 2612 | 2027-04-30 | 2027-04-30 | 0d | 2026-09-28 | 2026-09-28 | 169d |  | Ofgem | PMO,CPT,IPA,SRO | 5.0 |  | Programme Closure | 924.71 | Green | GREEN | MHHS-ART130 |  |  |  |
| 2614 | 1.11.4 | **Benefit Realisation Report** |  | 45d | 2027-03-08 | 2027-05-07 |  | 2027-03-08 | 2027-05-07 | 45d | 2026-08-04 | 2026-10-05 | 164d |  | N/A | N/A | 5.0 | N/A | Programme Closure |  |  |  |  |  |  |  |
| 2615 | 1.11.4.1 | Develop document |  | 20d | 2027-03-08 | 2027-04-02 | 2356FS-45d | 2027-03-08 | 2027-04-02 | 20d | 2026-08-04 | 2026-08-31 | 164d | 0d | PMO | CPT | 5.0 |  | Programme Closure | 871.33 | Green | GREEN |  |  |  |  |
| 2616 | 1.11.4.2 | Document review and update |  | 20d | 2027-04-05 | 2027-04-30 | 2615 | 2027-04-05 | 2027-04-30 | 20d | 2026-09-01 | 2026-09-28 | 164d | 0d | PP | PMO,CPT,IPA,SRO | 5.0 |  | Programme Closure | 899.33 | Green | GREEN |  |  |  |  |
| 2617 | 1.11.4.3 | Benefit Realisation Report approved | milestone | 0d | 2027-05-07 | 2027-05-07 | 2616FS+5d | 2027-05-07 | 2027-05-07 | 0d | 2026-10-05 | 2026-10-05 | 164d |  | PMO | CPT,PP,IPA,SRO | 5.0 |  | Programme Closure | 931.71 | Green | GREEN | MHHS-ART124 | T3-PC-0010 | PSG | T3 |
| 2618 | 1.11.5 | **Operating Model Gap Review with recommendations** |  | 45d | 2027-03-08 | 2027-05-07 |  | 2027-03-08 | 2027-05-07 | 45d | 2026-08-04 | 2026-10-05 | 164d |  | N/A | N/A | 5.0 | N/A | Programme Closure |  |  |  |  |  |  |  |
| 2619 | 1.11.5.1 | Develop document |  | 20d | 2027-03-08 | 2027-04-02 | 2356FS-45d | 2027-03-08 | 2027-04-02 | 20d | 2026-08-04 | 2026-08-31 | 164d | 0d | PMO | CPT | 5.0 |  | Programme Closure | 871.33 | Green | GREEN |  |  |  |  |
| 2620 | 1.11.5.2 | Document review and update |  | 20d | 2027-04-05 | 2027-04-30 | 2619 | 2027-04-05 | 2027-04-30 | 20d | 2026-09-01 | 2026-09-28 | 164d | 0d | PP | PMO,CPT,IPA,SRO | 5.0 |  | Programme Closure | 899.33 | Green | GREEN |  |  |  |  |
| 2621 | 1.11.5.3 | Operating Model Gap Review with recommendations approved | milestone | 0d | 2027-05-07 | 2027-05-07 | 2620FS+5d | 2027-05-07 | 2027-05-07 | 0d | 2026-10-05 | 2026-10-05 | 164d |  | Paul Pettitt | CPT,PP,IPA,SRO | 5.0 | Paul Pettitt | Programme Closure | 931.71 | Green | GREEN | MHHS-ART128 | T3-PC-0020 | DAG | T3 |
| 2622 | 1.11.6 | **Post-Implementation Review** |  | 45d | 2027-03-08 | 2027-05-07 |  | 2027-03-08 | 2027-05-07 | 45d | 2026-08-04 | 2026-10-05 | 164d |  | N/A | N/A | 5.0 | N/A | Programme Closure |  |  |  |  |  |  |  |
| 2623 | 1.11.6.1 | Develop document |  | 20d | 2027-03-08 | 2027-04-02 | 2356FS-45d | 2027-03-08 | 2027-04-02 | 20d | 2026-08-04 | 2026-08-31 | 164d | 0d | PMO | CPT | 5.0 |  | Programme Closure | 871.33 | Green | GREEN |  |  |  |  |
| 2624 | 1.11.6.2 | Document review and update |  | 20d | 2027-04-05 | 2027-04-30 | 2623 | 2027-04-05 | 2027-04-30 | 20d | 2026-09-01 | 2026-09-28 | 164d | 0d | PP | PMO,CPT,IPA,SRO | 5.0 |  | Programme Closure | 899.33 | Green | GREEN |  |  |  |  |
| 2625 | 1.11.6.3 | Post-Implementation Review approved | milestone | 0d | 2027-05-07 | 2027-05-07 | 2624FS+5d | 2027-05-07 | 2027-05-07 | 0d | 2026-10-05 | 2026-10-05 | 164d |  | PMO | CPT,PP,IPA,SRO | 5.0 |  | Programme Closure | 931.71 | Green | GREEN | MHHS-ART129 | T3-PC-0030 | PSG | T3 |

Notes:
- 2621: Action: 5/2 - PP said ask MB if belonged to him. MB says doesn't sit with him

| ID | WBS | Task | Type | Duration | Start | Finish | Predecessors | Complete | Remaining | Baseline start | Baseline finish | Baseline duration | Baseline 1 start | Baseline 1 finish | Total slack | Free slack | Constraint | Responsible | Involved | Update Version | MHHS Resource Name | MHHS Programme Phase | Task Status | Sched Status | RAG | Artefact ID | Milestone ID | Text29 | Tier | Text3 |
| --- | --- | --- | --- | --- | --- | --- | --- | --- | --- | --- | --- | --- | --- | --- | --- | --- | --- | --- | --- | --- | --- | --- | --- | --- | --- | --- | --- | --- | --- | --- |
| 2626 | 1.11.7 | **Reinforcement Guide** |  | 45d | 2027-03-08 | 2027-05-07 |  |  |  | 2027-03-08 | 2027-05-07 | 45d | 2026-08-04 | 2026-10-05 | 164d |  |  | N/A | N/A | 5.0 | N/A | Programme Closure |  |  |  |  |  |  |  |  |
| 2627 | 1.11.7.1 | Develop document |  | 20d | 2027-03-08 | 2027-04-02 | 2356FS-45d |  |  | 2027-03-08 | 2027-04-02 | 20d | 2026-08-04 | 2026-08-31 | 164d | 0d |  | PMO | CPT | 5.0 |  | Programme Closure | 871.33 | Green | GREEN |  |  |  |  |  |
| 2628 | 1.11.7.2 | Document review and update |  | 20d | 2027-04-05 | 2027-04-30 | 2627 |  |  | 2027-04-05 | 2027-04-30 | 20d | 2026-09-01 | 2026-09-28 | 164d | 0d |  | PP | PMO,CPT,IPA,SRO | 5.0 |  | Programme Closure | 899.33 | Green | GREEN |  |  |  |  |  |
| 2629 | 1.11.7.3 | Reinforcement Guide approved | milestone | 0d | 2027-05-07 | 2027-05-07 | 2628FS+5d |  |  | 2027-05-07 | 2027-05-07 | 0d | 2026-10-05 | 2026-10-05 | 164d |  |  | PMO | CPT,PP,IPA,SRO | 5.0 |  | Programme Closure | 931.71 | Green | GREEN | MHHS-ART133 | T3-PC-0040 | PSG | T3 |  |
| 2630 | 1.11.8 | **Material and Licenses Transfer** |  | 60d | 2027-04-05 | 2027-06-25 |  |  |  | 2027-04-05 | 2027-06-25 | 60d | 2026-09-08 | 2026-11-30 | 129d |  |  | N/A | N/A | 5.0 | N/A | Programme Closure |  |  |  |  |  |  |  |  |
| 2631 | 1.11.8.1 | Transfer of Programme material to Elexon and perpetual licenses as appropriate |  | 60d | 2027-04-05 | 2027-06-25 | 2589FF-5d |  |  | 2027-04-05 | 2027-06-25 | 60d | 2026-09-08 | 2026-11-30 | 129d |  |  | PMO | CPT,PP | 5.0 |  | Programme Closure | 899.33 | Green | GREEN | MHHS-ART139 |  |  |  |  |
| 2632 | 1.12 | **READINESS ASSESSMENTS** |  | 988d | 2023-09-05 A | 2027-06-17 |  | 23% | 764.9d | 2023-09-05 | 2027-06-17 | 849d | 2023-09-11 | 2026-12-04 | 135d |  |  | N/A | N/A |  | N/A | Readiness Assessments |  |  |  |  |  |  |  |  |
| 2633 | 1.12.1 | **Readiness Assessment 3 - Design and Build Progress Check and CP2 Check** |  | 60d | 2023-09-05 A | 2023-11-27 A |  | 100% |  | 2023-09-05 | 2023-11-27 | 50d | 2023-09-11 | 2023-11-17 |  |  |  | N/A | N/A | 5.5 | N/A | Readiness Assessments | M5,M6 |  |  |  |  |  |  |  |
| 2634 | 1.12.1.1 | Launch Readiness Assessment survey | milestone | 0d | 2023-09-05 A | 2023-09-05 A | 1225FS-40d | 100% |  | 2023-09-05 | 2023-09-05 | 0d | 2023-09-11 | 2023-09-11 |  |  |  | PPC |  | 5.5 | PPC | Readiness Assessments |  | Complete | COMPLETE |  |  |  |  |  |
| 2635 | 1.12.1.2 | PPs submit survey responses |  | 15d | 2023-09-05 A | 2023-09-25 A | 2634 | 100% |  | 2023-09-05 | 2023-09-25 | 15d | 2023-09-11 | 2023-09-29 |  |  |  | PP | PPC | 5.5 | PPC | Readiness Assessments |  | Complete | COMPLETE |  |  |  |  |  |
| 2636 | 1.12.1.3 | Analyse survey responses |  | 15d | 2023-09-26 A | 2023-10-16 A | 2635 | 100% |  | 2023-09-26 | 2023-10-16 | 15d | 2023-10-02 | 2023-10-20 |  |  |  | PPC | CPT | 5.5 | PPC | Readiness Assessments |  | Complete | COMPLETE |  |  |  |  |  |
| 2637 | 1.12.1.4 | Conduct deep-dive interviews (sample of PPs) |  | 15d | 2023-09-26 A | 2023-10-16 A | 2635 | 100% |  | 2023-09-26 | 2023-10-16 | 15d | 2023-10-02 | 2023-10-20 |  |  |  | PPC | CPT | 5.5 | PPC | Readiness Assessments |  | Complete | COMPLETE |  |  |  |  |  |
| 2638 | 1.12.1.5 | Produce Readiness Assessment Reports (Overall Report & Individual Participant Reports) |  | 25d | 2023-10-17 A | 2023-11-20 A | 2636, 2637 | 100% |  | 2023-10-17 | 2023-11-20 | 15d | 2023-10-23 | 2023-11-10 |  |  |  | PPC |  | 5.5 | PPC | Readiness Assessments |  | Complete | COMPLETE |  |  |  |  |  |
| 2639 | 1.12.1.6 | Readiness Assessment 3 - Design & Build Checkpoint 1 - Completed (incl. Readiness Assessment Report approval) | milestone | 0d | 2023-11-27 A | 2023-11-27 A | 2638FS+5d | 100% |  | 2023-11-27 | 2023-11-27 | 0d | 2023-11-17 | 2023-11-17 |  |  |  | CPT | PPC | 5.13 | PPC | Readiness Assessments |  | Complete | COMPLETE |  | T2-RA-0200 | PSG | T2 |  |
| 2640 | 1.12.2 | **Readiness Assessment 5 / 6 - Start of Qualification and Participant Readiness for M10 and M11 and CP3/CP4 check** |  | 47d | 2025-04-21 | 2025-06-24 |  |  |  | 2025-04-21 | 2025-06-24 | 49d | 2024-11-12 | 2025-01-17 | 652d |  |  | N/A | N/A | 5.0 | N/A | Readiness Assessments | M11 |  |  |  |  |  |  | D25 - RA6 Readiness Report |
| 2641 | 1.12.2.1 | Launch Readiness Assessment survey | milestone | 0d | 2025-04-21 | 2025-04-21 |  |  |  | 2025-04-21 | 2025-04-21 | 0d | 2024-11-12 | 2024-11-12 | 652d | 0d | start no earlier than 2025-04-21 | PPC |  | 5.0 | PPC | Readiness Assessments | 185.33 | Green | GREEN |  |  |  |  |  |
| 2642 | 1.12.2.2 | PPs submit survey responses |  | 15d | 2025-04-21 | 2025-05-09 | 2641 |  |  | 2025-04-21 | 2025-05-09 | 15d | 2024-11-12 | 2024-12-02 | 652d | 0d |  | PP | PPC | 5.0 | PPC | Readiness Assessments | 185.33 | Green | GREEN |  |  |  |  |  |
| 2643 | 1.12.2.3 | Analyse survey responses |  | 15d | 2025-05-12 | 2025-05-30 | 2642 |  |  | 2025-05-12 | 2025-05-30 | 15d | 2024-12-03 | 2024-12-23 | 652d | 0d |  | PPC | CPT | 5.0 | PPC | Readiness Assessments | 206.33 | Green | GREEN |  |  |  |  |  |
| 2644 | 1.12.2.4 | Conduct deep-dive interviews (sample of PPs) |  | 15d | 2025-05-12 | 2025-05-30 | 2642 |  |  | 2025-05-12 | 2025-05-30 | 15d | 2024-12-03 | 2024-12-23 | 652d | 0d |  | PPC | CPT | 5.0 | PPC | Readiness Assessments | 206.33 | Green | GREEN |  |  |  |  |  |
| 2645 | 1.12.2.5 | Produce Readiness Assessment Reports (Overall Report & Individual Participant Reports) |  | 15d | 2025-06-02 | 2025-06-20 | 2643, 2644 |  |  | 2025-06-02 | 2025-06-20 | 15d | 2024-12-24 | 2025-01-13 | 652d | 0d |  | PPC |  | 5.0 | PPC | Readiness Assessments | 227.33 | Green | GREEN |  |  |  |  |  |
| 2646 | 1.12.2.6 | Readiness Assessment 5 / 6 - Start of Qualification and Participant Readiness for M10 and M11 and CP3/CP4 check (incl. Readiness Assessment Report approval) Completed | milestone | 0d | 2025-06-24 | 2025-06-24 | 2645FS+2d |  |  | 2025-06-24 | 2025-06-24 | 0d | 2025-01-17 | 2025-01-17 | 652d | 0d |  | CPT | PPC | 5.18 | PPC | Readiness Assessments | 249.71 | Green | GREEN |  | T2-RA-0400 | PSG | T2 |  |
| 2647 | 1.12.3 | **Readiness Assessment 7 - Migration Checkpoint** |  | 49d | 2026-01-12 | 2026-03-19 |  |  |  | 2026-01-12 | 2026-03-19 | 49d | 2025-08-04 | 2025-10-09 | 460d |  |  | N/A | N/A | 5.0 | N/A | Readiness Assessments | M14 |  |  |  |  |  |  | D29 - RA8 Readiness Report |
| 2648 | 1.12.3.1 | Launch Readiness Assessment survey | milestone | 0d | 2026-01-12 | 2026-01-12 |  |  |  | 2026-01-12 | 2026-01-12 | 0d | 2025-08-04 | 2025-08-04 | 460d | 0d | start no earlier than 2026-01-12 | PPC |  | 5.0 | PPC | Readiness Assessments | 451.33 | Green | GREEN |  |  |  |  |  |
| 2649 | 1.12.3.2 | PPs submit survey responses |  | 15d | 2026-01-12 | 2026-01-30 | 2648 |  |  | 2026-01-12 | 2026-01-30 | 15d | 2025-08-04 | 2025-08-22 | 460d | 0d |  | PP | PPC | 5.0 | PPC | Readiness Assessments | 451.33 | Green | GREEN |  |  |  |  |  |
| 2650 | 1.12.3.3 | Analyse survey responses |  | 15d | 2026-02-02 | 2026-02-20 | 2649 |  |  | 2026-02-02 | 2026-02-20 | 15d | 2025-08-25 | 2025-09-12 | 460d | 0d |  | PPC | CPT | 5.0 | PPC | Readiness Assessments | 472.33 | Green | GREEN |  |  |  |  |  |
| 2651 | 1.12.3.4 | Conduct deep-dive interviews (sample of PPs) |  | 15d | 2026-02-02 | 2026-02-20 | 2649 |  |  | 2026-02-02 | 2026-02-20 | 15d | 2025-08-25 | 2025-09-12 | 460d | 0d |  | PPC | CPT | 5.0 | PPC | Readiness Assessments | 472.33 | Green | GREEN |  |  |  |  |  |
| 2652 | 1.12.3.5 | Produce Readiness Assessment Reports (Overall Report & Individual Participant Reports) |  | 15d | 2026-02-23 | 2026-03-13 | 2650, 2651 |  |  | 2026-02-23 | 2026-03-13 | 15d | 2025-09-15 | 2025-10-03 | 460d | 0d |  | PPC |  | 5.0 | PPC | Readiness Assessments | 493.33 | Green | GREEN |  |  |  |  |  |
| 2653 | 1.12.3.6 | Readiness Assessment 7 - Migration Checkpoint - Completed (incl. Readiness Assessment Report approval) | milestone | 0d | 2026-03-19 | 2026-03-19 | 2652FS+4d |  |  | 2026-03-19 | 2026-03-19 | 0d | 2025-10-09 | 2025-10-09 | 460d | 0d |  | CPT | PPC | 5.0 | PPC | Readiness Assessments | 517.71 | Green | GREEN |  | T2-RA-0600 | PSG | T2 |  |

Notes:
- 2637: 16/11- FD confirmed activity didn't take place for RA3 because responses did not warrant follow-up
- 2639: 16/11-RA3 outputs and initial findings shared with PSG to support M9 decision making. Individual reports and final closure report being finalised. No impact to Programme timelines or activities
- 2646: 08/02/2024 Name change approval at PSG on 07/02/24 from 'Readiness Assessment 5 - Start of Qualification - Completed (incl. Readiness Assessment Report approval)'

| ID | WBS | Task | Type | Duration | Start | Finish | Predecessors | Complete | Remaining | Baseline start | Baseline finish | Baseline duration | Baseline 1 start | Baseline 1 finish | Total slack | Free slack | Constraint | Responsible | Involved | Text3 | Task Status | Update Version | MHHS Resource Name | MHHS Programme Phase | Sched Status | RAG | Milestone ID | Text29 | Tier |
| --- | --- | --- | --- | --- | --- | --- | --- | --- | --- | --- | --- | --- | --- | --- | --- | --- | --- | --- | --- | --- | --- | --- | --- | --- | --- | --- | --- | --- | --- |
| 2654 | 1.12.4 | **Readiness Assessment 8 - Ready to Accept New MPANs** |  | 49d | 2026-08-06 | 2026-10-13 |  |  |  | 2026-08-06 | 2026-10-13 | 49d | 2026-01-06 | 2026-03-13 | 312d |  |  | N/A | N/A | D29 - RA8 Readiness Report | M14 | 5.0 | N/A | Readiness Assessments |  |  |  |  |  |
| 2655 | 1.12.4.1 | Launch Readiness Assessment survey | milestone | 0d | 2026-08-06 | 2026-08-06 | 1968FS-60d |  |  | 2026-08-06 | 2026-08-06 | 0d | 2026-01-06 | 2026-01-06 | 312d | 0d |  | PPC |  |  | 657.33 | 5.0 | PPC | Readiness Assessments | Green | GREEN |  |  |  |
| 2656 | 1.12.4.2 | PPs submit survey responses |  | 15d | 2026-08-06 | 2026-08-26 | 2655 |  |  | 2026-08-06 | 2026-08-26 | 15d | 2026-01-06 | 2026-01-26 | 312d | 0d |  | PP | PPC |  | 657.33 | 5.0 | PPC | Readiness Assessments | Green | GREEN |  |  |  |
| 2657 | 1.12.4.3 | Analyse survey responses |  | 15d | 2026-08-27 | 2026-09-16 | 2656 |  |  | 2026-08-27 | 2026-09-16 | 15d | 2026-01-27 | 2026-02-16 | 312d | 0d |  | PPC | CPT |  | 678.33 | 5.0 | PPC | Readiness Assessments | Green | GREEN |  |  |  |
| 2658 | 1.12.4.4 | Conduct deep-dive interviews (sample of PPs) |  | 15d | 2026-08-27 | 2026-09-16 | 2656 |  |  | 2026-08-27 | 2026-09-16 | 15d | 2026-01-27 | 2026-02-16 | 312d | 0d |  | PPC | CPT |  | 678.33 | 5.0 | PPC | Readiness Assessments | Green | GREEN |  |  |  |
| 2659 | 1.12.4.5 | Produce Readiness Assessment Reports (Overall Report & Individual Participant Reports) |  | 15d | 2026-09-17 | 2026-10-07 | 2657, 2658 |  |  | 2026-09-17 | 2026-10-07 | 15d | 2026-02-17 | 2026-03-09 | 312d | 0d |  | PPC |  |  | 699.33 | 5.0 | PPC | Readiness Assessments | Green | GREEN |  |  |  |
| 2660 | 1.12.4.6 | Readiness Assessment 8 - Ready to Accept New MPANs - Completed (incl. Readiness Assessment Report approval) | milestone | 0d | 2026-10-13 | 2026-10-13 | 2659FS+4d |  |  | 2026-10-13 | 2026-10-13 | 0d | 2026-03-13 | 2026-03-13 | 312d | 0d |  | CPT | PPC |  | 725.71 | 5.0 | PPC | Readiness Assessments | Green | GREEN | T2-RA-0700 | PSG | T2 |
| 2661 | 1.12.5 | **Readiness Assessment 9 - Ready for New Settlement Timetable and CP5 Check** |  | 49d | 2027-04-12 | 2027-06-17 |  |  |  | 2027-04-12 | 2027-06-17 | 49d | 2026-09-29 | 2026-12-04 | 135d |  |  | N/A | N/A | D32 - RA10 Readiness Report | M16 | 5.0 | N/A | Readiness Assessments |  |  |  |  |  |
| 2662 | 1.12.5.1 | Launch Readiness Assessment survey | milestone | 0d | 2027-04-12 | 2027-04-12 | 2589FS-60d |  |  | 2027-04-12 | 2027-04-12 | 0d | 2026-09-29 | 2026-09-29 | 135d | 0d |  | PPC |  |  | 906.33 | 5.0 | PPC | Readiness Assessments | Green | GREEN |  |  |  |
| 2663 | 1.12.5.2 | PPs submit survey responses |  | 15d | 2027-04-12 | 2027-04-30 | 2662 |  |  | 2027-04-12 | 2027-04-30 | 15d | 2026-09-29 | 2026-10-19 | 135d | 0d |  | PP | PPC |  | 906.33 | 5.0 | PPC | Readiness Assessments | Green | GREEN |  |  |  |
| 2664 | 1.12.5.3 | Analyse survey responses |  | 15d | 2027-05-03 | 2027-05-21 | 2663 |  |  | 2027-05-03 | 2027-05-21 | 15d | 2026-10-20 | 2026-11-09 | 135d | 0d |  | PPC | CPT |  | 927.33 | 5.0 | PPC | Readiness Assessments | Green | GREEN |  |  |  |
| 2665 | 1.12.5.4 | Conduct deep-dive interviews (sample of PPs) |  | 15d | 2027-05-03 | 2027-05-21 | 2663 |  |  | 2027-05-03 | 2027-05-21 | 15d | 2026-10-20 | 2026-11-09 | 135d | 0d |  | PPC | CPT |  | 927.33 | 5.0 | PPC | Readiness Assessments | Green | GREEN |  |  |  |
| 2666 | 1.12.5.5 | Produce Readiness Assessment Reports (Overall Report & Individual Participant Reports) |  | 15d | 2027-05-24 | 2027-06-11 | 2664, 2665 |  |  | 2027-05-24 | 2027-06-11 | 15d | 2026-11-10 | 2026-11-30 | 135d | 0d |  | PPC |  |  | 948.33 | 5.0 | PPC | Readiness Assessments | Green | GREEN |  |  |  |
| 2667 | 1.12.5.6 | Readiness Assessment 9 - Readiness for New Settlement Timetable - Completed (incl. Readiness Assessment Report approval) | milestone | 0d | 2027-06-17 | 2027-06-17 | 2666FS+4d |  |  | 2027-06-17 | 2027-06-17 | 0d | 2026-12-04 | 2026-12-04 | 135d | 0d |  | CPT | PPC |  | 972.71 | 5.0 | PPC | Readiness Assessments | Green | GREEN | T2-RA-0800 | PSG | T2 |
| 2668 | 1.12.6 | **Readiness Assessments - Tier 1 Milestones** |  | 517d | 2025-06-24 | 2027-06-17 |  |  |  | 2025-06-24 | 2027-06-17 | 799d | 2023-11-17 | 2026-12-04 | 135d |  |  | N/A | N/A |  |  | 5.0 | N/A | Readiness Assessments |  |  |  |  |  |
| 2669 | 1.12.6.1 | Readiness Assessment 6 - Start of Migration - Completed (incl. Readiness Assessment Report approval) | milestone | 0d | 2025-06-24 | 2025-06-24 | 2646 |  |  | 2025-06-24 | 2025-06-24 | 0d | 2025-04-04 | 2025-04-04 | 652d |  | finish no earlier than 2025-04-04 | CPT | PPC |  | 249.71 | 5.0 | PPC | Readiness Assessments | Green | GREEN | T2-RA-0500 | PSG | T2 |
| 2670 | 1.12.6.2 | Readiness Assessment 7 - Migration Checkpoint - Completed (incl. Readiness Assessment Report approval) | milestone | 0d | 2026-03-19 | 2026-03-19 | 2653 |  |  | 2026-03-19 | 2026-03-19 | 0d | 2025-10-09 | 2025-10-09 | 460d |  |  | CPT | PPC |  | 517.71 | 5.0 | PPC | Readiness Assessments | Green | GREEN | T2-RA-0600 | PSG | T2 |
| 2671 | 1.12.6.3 | Readiness Assessment 8 - Ready to Accept New MPANs - Completed (incl. Readiness Assessment Report approval) | milestone | 0d | 2026-10-13 | 2026-10-13 | 2660 |  |  | 2026-10-13 | 2026-10-13 | 0d | 2026-03-13 | 2026-03-13 | 312d |  |  | CPT | PPC |  | 725.71 | 5.0 | PPC | Readiness Assessments | Green | GREEN | T2-RA-0700 | PSG | T2 |
| 2672 | 1.12.6.4 | Readiness Assessment 9 - Readiness for New Settlement Timetable - Completed (incl. Readiness Assessment Report approval) | milestone | 0d | 2027-06-17 | 2027-06-17 | 2667 |  |  | 2027-06-17 | 2027-06-17 | 0d | 2026-12-04 | 2026-12-04 | 135d |  |  | CPT | PPC |  | 972.71 | 5.0 | PPC | Readiness Assessments | Green | GREEN | T2-RA-0800 | PSG | T2 |
| 2673 | 1.13 | **CONTROL POINTS** |  | 1204d | 2022-11-10 A | 2027-06-23 |  | 51% | 591.8d | 2022-11-10 | 2027-06-23 | 1063d | 2022-11-10 | 2026-12-07 | 132d |  |  | N/A | N/A |  |  |  | N/A | Control Points |  |  |  |  |  |
| 2674 | 1.13.1 | **Control Point 1 - Start of System Design, Build & Test** |  | 20d | 2022-11-10 A | 2022-12-07 A |  | 100% |  | 2022-11-10 | 2022-12-07 | 20d | 2022-11-10 | 2022-12-07 |  |  |  | N/A | N/A |  |  | 5.0 | N/A | Control Points |  |  |  |  |  |
| 2675 | 1.13.1.1 | Control Point 1 Preparation (incl. Control Point Report development and review) |  | 15d | 2022-11-10 A | 2022-11-30 A | 2676SS-20d | 100% |  | 2022-11-10 | 2022-11-30 | 15d | 2022-11-10 | 2022-11-30 |  |  |  | CPT | PMO |  |  | 5.0 | PMO | Control Points | Complete | COMPLETE |  |  |  |
| 2676 | 1.13.1.2 | Control Point 1 - Start of System Design, Build & Test (incl. Control Point Report approval) | milestone | 0d | 2022-12-07 A | 2022-12-07 A |  | 100% |  | 2022-12-07 | 2022-12-07 | 0d | 2022-12-07 | 2022-12-07 |  |  | must finish on 2022-12-07 | CPT | PMO | D24 - CP2 Approval |  | 5.0 | PMO | Control Points | Complete | COMPLETE | T1-CP-1000 | PSG | T1 |
| 2677 | 1.13.2 | **Control Point 2 - Start of Integration & Test** |  | 20d | 2023-10-02 A | 2023-10-30 A |  | 100% |  | 2023-10-02 | 2023-10-30 | 20d | 2023-10-02 | 2023-10-30 |  |  |  | N/A | N/A |  |  | 5.0 | N/A | Control Points |  |  |  |  |  |
| 2678 | 1.13.2.1 | Control Point 2 Preparation (incl. Control Point Report development and review) |  | 15d | 2023-10-02 A | 2023-10-20 A | 2679SS-20d | 100% |  | 2023-10-02 | 2023-10-20 | 15d | 2023-10-02 | 2023-10-20 |  |  |  | CPT | PMO |  |  | 5.0 | PMO | Control Points | Complete | COMPLETE |  |  |  |
| 2679 | 1.13.2.2 | Control Point 2 - Start of Integration & Test (incl. Control Point Report approval) | milestone | 0d | 2023-10-30 A | 2023-10-30 A | 1225 | 100% |  | 2023-10-30 | 2023-10-30 | 0d | 2023-10-30 | 2023-10-30 |  |  |  | CPT | PMO | D24 - CP2 Approval |  | 5.11 | PMO | Control Points | Complete | COMPLETE | T1-CP-2000 | PSG | T1 |

| ID | WBS | Task | Type | Duration | Start | Finish | Predecessors | Complete | Remaining | Baseline start | Baseline finish | Baseline duration | Baseline 1 start | Baseline 1 finish | Total slack | Free slack | Responsible | Involved | Text3 | Update Version | MHHS Resource Name | MHHS Programme Phase | Task Status | Sched Status | RAG | Milestone ID | Text29 | Tier |
| --- | --- | --- | --- | --- | --- | --- | --- | --- | --- | --- | --- | --- | --- | --- | --- | --- | --- | --- | --- | --- | --- | --- | --- | --- | --- | --- | --- | --- |
| 2680 | 1.13.3 | **Control Point 3/4 - Readiness for Migration** |  | 20d | 2025-08-21 | 2025-09-18 |  |  |  | 2025-08-21 | 2025-09-18 | 20d | 2025-03-03 | 2025-03-28 | 591d |  | N/A | N/A | D26 - CP3 Approval | 5.0 | N/A | Control Points |  |  |  |  |  |  |
| 2681 | 1.13.3.1 | Control Point 3/4 Preparation (incl. Control Point Report development and review) |  | 14d | 2025-08-21 | 2025-09-09 | 2682SS-20d |  |  | 2025-08-21 | 2025-09-09 | 14d | 2025-03-03 | 2025-03-21 | 597d |  | CPT | PMO |  | 5.0 | PMO | Control Points | 307.33 | Green | GREEN |  |  |  |
| 2682 | 1.13.3.2 | Control Point 3/4 - Readiness for Migration (incl. Control Point Report approval) | milestone | 0d | 2025-09-18 | 2025-09-18 | 1493FS-5d |  |  | 2025-09-18 | 2025-09-18 | 0d | 2025-03-28 | 2025-03-28 | 591d | 0d | CPT | PMO |  | 5.0 | PMO | Control Points | 335.33 | Green | GREEN | T1-CP-3000 | PSG | T1 |
| 2683 | 1.13.4 | **Control Point 5 - Cut Over to New Settlement Timetable** |  | 20d | 2027-05-26 | 2027-06-23 |  |  |  | 2027-05-26 | 2027-06-23 | 20d | 2026-11-10 | 2026-12-07 | 132d |  | N/A | N/A | D33 - Control Point 6 Approval | 5.0 | N/A | Control Points | M16 |  |  |  |  |  |
| 2684 | 1.13.4.1 | Control Point 5 Preparation (incl. Control Point Report development and review) |  | 15d | 2027-05-26 | 2027-06-15 | 2685SS-20d |  |  | 2027-05-26 | 2027-06-15 | 15d | 2026-11-10 | 2026-11-30 | 137d |  | CPT | PP |  | 5.0 | PMO | Control Points | 950.33 | Green | GREEN |  |  |  |
| 2685 | 1.13.4.2 | Control Point 5 - Cut Over to New Settlement Timetable (incl. Control Point Report approval) | milestone | 0d | 2027-06-23 | 2027-06-23 | 2589FS-8d |  |  | 2027-06-23 | 2027-06-23 | 0d | 2026-12-07 | 2026-12-07 | 132d | 0d | CPT | CPT | D33 - Control Point 6 Approval | 5.0 | PMO | Control Points | 978.33 | Green | GREEN | T1-CP-4000 | PSG | T1 |
| 2686 | 1.13.5 | **Control Points - Tier 1 Milestones** |  | 1184d | 2022-12-07 A | 2027-06-23 |  |  | 1184d | 2022-12-07 | 2027-06-23 | 1043d | 2022-12-07 | 2026-12-07 | 132d |  | N/A | N/A |  | 5.0 | N/A | Control Points |  |  |  |  |  |  |
| 2687 | 1.13.5.1 | Control Point 1 - Start of System Design, Build & Test (incl. Control Point Report approval) | milestone | 0d | 2022-12-07 A | 2022-12-07 A | 2676SS | 100% |  | 2022-12-07 | 2022-12-07 | 0d | 2022-12-07 | 2022-12-07 |  |  | CPT | PMO |  | 5.0 | PMO | Control Points |  | Complete | COMPLETE | T1-CP-1000 | PSG | T1 |
| 2688 | 1.13.5.2 | Control Point 2 - Start of Integration & Test (incl. Control Point Report approval) | milestone | 0d | 2023-10-30 A | 2023-10-30 A | 2679SS | 100% |  | 2023-10-30 | 2023-10-30 | 0d | 2023-10-30 | 2023-10-30 |  |  | CPT | PMO | D24 - CP2 Approval | 5.11 | PMO | Control Points |  | Complete | COMPLETE | T1-CP-2000 | PSG | T1 |
| 2689 | 1.13.5.3 | Control Point 3/4 - Readiness for Migration (incl. Control Point Report approval) | milestone | 0d | 2025-09-18 | 2025-09-18 | 2682SS |  |  | 2025-09-18 | 2025-09-18 | 0d | 2025-03-28 | 2025-03-28 | 591d |  | CPT | PMO |  | 5.0 | PMO | Control Points | 335.33 | Green | GREEN | T1-CP-3000 | PSG | T1 |
| 2690 | 1.13.5.4 | Control Point 5 - Cut Over to New Settlement Timetable (incl. Control Point Report approval) | milestone | 0d | 2027-06-23 | 2027-06-23 | 2685SS |  |  | 2027-06-23 | 2027-06-23 | 0d | 2026-12-07 | 2026-12-07 | 132d |  | CPT | CPT | D33 - Control Point 6 Approval | 5.0 | PMO | Control Points | 978.33 | Green | GREEN | T1-CP-4000 | PSG | T1 |
| 2691 | 1.14 | **MILESTONE RANGE CHECKPOINTS** |  | 1160d? | 2022-10-31 | 2027-04-12 |  |  |  | 2022-10-31 | 2027-04-12 | 436d | 2025-01-13 | 2026-09-15 | 184d |  | N/A | N/A |  |  | N/A | Milestone Range Checkpoints |  |  |  |  |  |  |
| 2692 | 1.14.1 | **M10, M11, M12 and M13 milestone checkpoint** |  | 0d | 2025-07-31 | 2025-07-31 |  |  |  | 2025-07-31 | 2025-07-31 | 0d | 2025-01-13 | 2025-01-13 | 626d |  | N/A | N/A |  | 5.0 | N/A | Milestone Range Checkpoints |  |  |  |  |  |  |
| 2693 | 1.14.1.1 | M10, M11, M12, and M13 milestone checkpoint - date approval | milestone | 0d | 2025-07-31 | 2025-07-31 | 2352FS-3mo, 2354FS-3mo, 2350FS-3mo, 1493FS-3mo |  |  | 2025-07-31 | 2025-07-31 | 0d | 2025-01-13 | 2025-01-13 | 626d |  | CPT | CPT |  | 5.0 | PMO | Milestone Range Checkpoints | 286.33 | Green | GREEN | T2-MR-0100 | PSG | T2 |
| 2694 | 1.14.2 | **M14 milestone checkpoint** |  | 0d | 2026-08-06 | 2026-08-06 |  |  |  | 2026-08-06 | 2026-08-06 | 0d | 2025-12-23 | 2025-12-23 | 361d |  | N/A | N/A |  | 5.0 | N/A | Milestone Range Checkpoints |  |  |  |  |  |  |
| 2695 | 1.14.2.1 | M14 milestone checkpoint - date approval | milestone | 0d | 2026-08-06 | 2026-08-06 | 1968FS-3mo |  |  | 2026-08-06 | 2026-08-06 | 0d | 2025-12-23 | 2025-12-23 | 361d |  | CPT | CPT |  | 5.0 | PMO | Milestone Range Checkpoints | 657.33 | Green | GREEN | T2-MR-0200 | PSG | T2 |
| 2696 | 1.14.3 | **M15 milestone checkpoint** |  | 0d | 2027-02-15 | 2027-02-15 |  |  |  | 2027-02-15 | 2027-02-15 | 0d | 2026-07-14 | 2026-07-14 | 224d |  | N/A | N/A |  | 5.0 | N/A | Milestone Range Checkpoints |  |  |  |  |  |  |
| 2697 | 1.14.3.1 | M15 milestone checkpoint - date approval | milestone | 0d | 2027-02-15 | 2027-02-15 | 2356FS-3mo |  |  | 2027-02-15 | 2027-02-15 | 0d | 2026-07-14 | 2026-07-14 | 224d |  | CPT | CPT |  | 5.0 | PMO | Milestone Range Checkpoints | 850.33 | Green | GREEN | T2-MR-0300 | PSG | T2 |
| 2698 | 1.14.4 | **M16 milestone checkpoint** |  | 1160d? | 2022-10-31 | 2027-04-12 |  |  |  | 2022-10-31 | 2027-04-12 | 0d | 2026-09-15 | 2026-09-15 | 184d |  | N/A | N/A |  | 5.0 | N/A | Milestone Range Checkpoints |  |  |  |  |  |  |
| 2699 | 1.14.4.1 | M16 milestone checkpoint - date approval | milestone | 0d | 2027-04-12 | 2027-04-12 | 2589FS-3mo |  |  | 2027-04-12 | 2027-04-12 | 0d | 2026-09-15 | 2026-09-15 | 184d |  | CPT | CPT |  | 5.0 | PMO | Milestone Range Checkpoints | 906.33 | Green | GREEN | T2-MR-0400 | PSG | T2 |
