# Outline ELEXON Plan_kc

Schedule from MS Project, 2022-10-31 to 2027-12-23, status date 2024-10-21, A marks actual dates.

## Calendars

- Standard: Mon-Fri 08:00-12:00, 13:00-17:00; Sat-Sun off.

## Resources

| Resource |
| --- |
| PMO |
| SI |
| PPC |
| Lead Workstream |
| CPT |
| PP |
| SI Design |
| SI Design |
| SI Design |
| Design |
| SI DevOps |
| SI Test |
| PSG |
| DAG |
| TMAG |
| CCAG |
| Code drafters (SRO Design Team |
| Code Bodies) |
| CCAG PM |
| Programme Participants |
| Code drafters |
| CDWG |
| SRO Design Team |
| Code Bodies |
| Ofgem |
| Elexon resources TBC |
| LDP Programme Manager |
| SRO Client Programme Director |
| IPA |
| LDP |
| SRO |
| )) |
| ? |
| TBC |
| OOC |
| MHHSP |
| Adrian Page |
| Amy Clayton |
| Anand Kaveripatna |
| Berlinda Kugara |
| Cesar Lopes |
| Charlie Blanks |
| Chetan Ubale |
| Daniel Callender |
| Daniel Gee |
| David Hollinshead |
| Dean Bailey |
| Dominic Mooney |
| Elayaraja Jeyaraman |
| Georgi Rabotov |
| Giles Clayden |
| Helen Richardson |
| Ishti Bhatti |
| Jafer Shah |
| Jason Brogden |
| John Edmonds Bell |
| John Wiggins |
| Karthikeyan Ganesan |
| Kasimali Hajiyani |
| Kate Goodman |
| Keegan Moodley |
| Keith Clark |
| Keith Lawlor |
| kevin Davis |
| Kishore Konduru |
| Kyle Abraham |
| Mahjabeen Newaz |
| Martin Freeman |
| Matt Hall |
| Matthew Breen |
| Michael Inije |
| Michael Walton |
| Ming Li |
| Nathalia Revlien |
| Nick Sewell |
| Nigel Hunt |
| Oskar Cahill |
| Paul Pettitt |
| Rakhee Shah |
| Rebecca Farooq |
| Renu Rathor |
| Robert Short |
| Robert Topley |
| Saadia Sajjad |
| Sean Tuffy |
| Shaid Hussain |
| Sharmeen Shaikh |
| Simon Berry |
| Steve Bradford |
| Steve Weston |
| Taaran Suri |
| Waseem Mohammed |
| Zak Hussain |
| berli |
| SI Migration |
| v |
| Andrew Margan |
| Lee Cox |
| DIP SP |
| DIPS SP |
| DIPSP |
| Ian Smith |
| N/A |
| SIT Component Integration Testing 2 Preparation Complete (incl. approval of SI SIT Component Integration Test Readiness Report) |
| Nich |
| Nicola Farley |
| Warren Fulton |
| Richard Puddephatt |
| Matthew Bray |
| Programme |
| LDSOs |
| Ben Wickins |
| paul |
| LDSO |
| Simon chidwick |
| Stuart Scott |
| MHHS Programme |
| Claire Silk |
| Laura Kennedy |
| Rowan B |
| FD |
| MB |
| AM |
| Roger Robar |
| Laura Kennedy. |

## Schedule

| ID | WBS | Task | Type | Duration | Start | Finish | Complete | Remaining | Baseline start | Baseline finish | Baseline duration | Baseline 1 start | Baseline 1 finish | Total slack | Constraint | Baseline cost | Responsible | Involved | Update Version | MHHS Resource Name | Sched Status | RAG | Text9 | Task Status | Text3 |
| --- | --- | --- | --- | --- | --- | --- | --- | --- | --- | --- | --- | --- | --- | --- | --- | --- | --- | --- | --- | --- | --- | --- | --- | --- | --- |
| 1 | 1 | **PROGRAMME PLAN.** |  | 1344d? | 2022-10-31 A | 2027-12-23 | 52% | 642.01d? | 2022-10-31 | 2027-12-23 | 1195d |  |  |  |  | -0 | N/A | N/A | 5.0 | N/A |  |  |  |  |  |
| 2 | 1.1 | MHHS Programme Start | milestone | 0d | 2022-10-31 A | 2022-10-31 A | 100% |  | 2022-10-31 | 2022-10-31 | 0d |  |  |  |  |  | N/A | N/A | 5.7 | N/A | Complete | COMPLETE |  |  |  |
| 3 | 1.2 | **PROGRAMME MANAGEMENT** |  | 1089d | 2022-10-31 A | 2026-12-31 | 44% | 609.27d | 2022-10-31 | 2026-12-31 | 1089d | 2022-10-31 | 2026-12-31 | 255d |  |  | N/A | N/A | 5.0 | N/A |  |  |  |  |  |
| 4 | 1.2.1 | **Programme Management** |  | 1089d | 2022-10-31 A | 2026-12-31 | 43% | 616d | 2022-10-31 | 2026-12-31 | 1089d | 2022-10-31 | 2026-12-31 | 255d |  |  | N/A | N/A | 5.0 | N/A |  |  | Programme Management | M10 |  |
| 5 | 1.2.1.1 | Sprint-based prioritisation planning and execution |  | 1089d | 2022-10-31 A | 2026-12-31 | 43% | 616d | 2022-10-31 | 2026-12-31 | 1089d | 2022-10-31 | 2026-12-31 | 255d | finish no earlier than 2026-12-31 |  | PMO | CPT | 5.0 | N/A | Green | GREEN | Programme Management |  |  |
| 6 | 1.2.1.2 | Programme governance secretariat |  | 1089d | 2022-10-31 A | 2026-12-31 | 43% | 616d | 2022-10-31 | 2026-12-31 | 1089d | 2022-10-31 | 2026-12-31 | 255d |  |  | PMO | CPT | 5.0 | N/A | Green | GREEN | Programme Management |  |  |
| 7 | 1.2.1.3 | RAID management and reporting |  | 1089d | 2022-10-31 A | 2026-12-31 | 43% | 616d | 2022-10-31 | 2026-12-31 | 1089d | 2022-10-31 | 2026-12-31 | 255d |  |  | PMO | CPT | 5.0 | N/A | Green | GREEN | Programme Management |  |  |
| 8 | 1.2.1.4 | Tracking against Programme outcomes and KPIs |  | 1089d | 2022-10-31 A | 2026-12-31 | 43% | 616d | 2022-10-31 | 2026-12-31 | 1089d | 2022-10-31 | 2026-12-31 | 255d |  |  | PMO | CPT | 5.0 | N/A | Green | GREEN | Programme Management |  |  |
| 9 | 1.2.1.5 | Change control and reporting |  | 1089d | 2022-10-31 A | 2026-12-31 | 43% | 616d | 2022-10-31 | 2026-12-31 | 1089d | 2022-10-31 | 2026-12-31 | 255d |  |  | PMO | CPT | 5.0 | N/A | Green | GREEN | Programme Management |  |  |
| 10 | 1.2.1.6 | Ongoing identification of lessons learned relating to the PMO and implementation of improvements |  | 1089d | 2022-10-31 A | 2026-12-31 | 43% | 616d | 2022-10-31 | 2026-12-31 | 1089d | 2022-10-31 | 2026-12-31 | 255d |  |  | PMO | CPT | 5.0 | N/A | Green | GREEN | Programme Management |  |  |
| 11 | 1.2.2 | **Programme Internal Assurance Reviews** |  | 1089d | 2022-10-31 A | 2026-12-31 | 43% | 616d | 2022-10-31 | 2026-12-31 | 1089d | 2022-10-31 | 2026-12-31 | 255d |  |  | N/A | N/A | 5.0 | N/A |  |  | Programme Management | M9 | D18A - Quarterly Assurance Report |
| 12 | 1.2.2.1 | Programme Internal Assurance Reviews |  | 1089d | 2022-10-31 A | 2026-12-31 | 43% | 616d | 2022-10-31 | 2026-12-31 | 1089d | 2022-10-31 | 2026-12-31 | 255d |  |  | CPT | PMO | 5.0 | N/A | Green | GREEN | Programme Management |  | D18A - Quarterly Assurance Report |
| 13 | 1.2.3 | **Engagement with PPs** |  | 1089d | 2022-10-31 A | 2026-12-31 | 43% | 615.89d | 2022-10-31 | 2026-12-31 | 1089d | 2022-10-31 | 2026-12-31 | 255d |  |  | N/A | N/A | 5.0 | N/A |  |  | Programme Management | M5,M6 |  |
| 14 | 1.2.3.1 | Ongoing PP liaison activities |  | 1089d | 2022-10-31 A | 2026-12-31 | 43% | 616d | 2022-10-31 | 2026-12-31 | 1089d | 2022-10-31 | 2026-12-31 | 255d |  |  | PPC | CPT | 5.0 | N/A | Green | GREEN | Programme Management |  |  |
| 15 | 1.2.3.2 | Milestone and Control Point objective setting |  | 1089d | 2022-10-31 A | 2026-12-31 | 43% | 616d | 2022-10-31 | 2026-12-31 | 1089d | 2022-10-31 | 2026-12-31 | 255d |  |  | PPC | CPT | 5.0 | N/A | Green | GREEN | Programme Management |  |  |
| 16 | 1.2.3.3 | Reporting |  | 1089d | 2022-10-31 A | 2026-12-31 | 43% | 616d | 2022-10-31 | 2026-12-31 | 1089d | 2022-10-31 | 2026-12-31 | 255d |  |  | PPC |  | 5.0 | N/A | Green | GREEN | Programme Management |  |  |
| 17 | 1.2.3.4 | **PP Engagement Events** |  | 1089d | 2022-10-31 A | 2026-12-31 | 43% | 616d | 2022-10-31 | 2026-12-31 | 1089d | 2022-10-31 | 2026-12-31 | 255d |  |  | N/A | N/A | 5.0 | N/A |  |  | Programme Management |  |  |
| 18 | 1.2.3.4.1 | Bilateral meetings |  | 1089d | 2022-10-31 A | 2026-12-31 | 43% | 616d | 2022-10-31 | 2026-12-31 | 1089d | 2022-10-31 | 2026-12-31 | 255d |  |  | PPC | CPT | 5.0 | N/A | Green | GREEN | Programme Management |  |  |
| 19 | 1.2.3.4.2 | Monthly webinars |  | 1089d | 2022-10-31 A | 2026-12-31 | 43% | 616d | 2022-10-31 | 2026-12-31 | 1089d | 2022-10-31 | 2026-12-31 | 255d |  |  | PPC | CPT | 5.0 | N/A | Green | GREEN | Programme Management |  |  |
| 20 | 1.2.3.4.3 | Open days |  | 1089d | 2022-10-31 A | 2026-12-31 | 43% | 616d | 2022-10-31 | 2026-12-31 | 1089d | 2022-10-31 | 2026-12-31 | 255d |  |  | PPC | CPT | 5.0 | N/A | Green | GREEN | Programme Management |  |  |
| 21 | 1.2.3.5 | **PP Communications** |  | 1088d | 2022-10-31 A | 2026-12-30 | 43% | 615d | 2022-10-31 | 2026-12-30 | 1088d | 2022-10-31 | 2026-12-30 | 256d |  |  | N/A | N/A | 5.0 | N/A |  |  | Programme Management |  |  |
| 22 | 1.2.3.5.1 | The Clock updates (weekly) |  | 1088d | 2022-10-31 A | 2026-12-30 | 43% | 615d | 2022-10-31 | 2026-12-30 | 1088d | 2022-10-31 | 2026-12-30 | 256d |  |  | PPC |  | 5.0 | N/A | Green | GREEN | Programme Management |  |  |
| 23 | 1.2.3.5.2 | Maintain and update content on public-facing Portal (and ongoing feedback reviews to identify and implement Portal improvements) |  | 1088d | 2022-10-31 A | 2026-12-30 | 43% | 615d | 2022-10-31 | 2026-12-30 | 1088d | 2022-10-31 | 2026-12-30 | 256d |  |  | PPC |  | 5.0 | N/A | Green | GREEN | Programme Management |  |  |
| 24 | 1.2.4 | **Code Change Support / Other Programme Alignment** |  | 1089d | 2022-10-31 A | 2026-12-31 | 43% | 616d | 2022-10-31 | 2026-12-31 | 1089d | 2022-10-31 | 2026-12-31 | 255d |  |  | N/A | N/A | 5.0 | N/A |  |  | Programme Management | M6 | D17 - Code Change Report & Recommendations |
| 25 | 1.2.4.1 | Support DCC/BEIS on SEC change |  | 1089d | 2022-10-31 A | 2026-12-31 | 43% | 616d | 2022-10-31 | 2026-12-31 | 1089d | 2022-10-31 | 2026-12-31 | 255d |  |  | CPT |  | 5.0 | N/A | Green | GREEN | Programme Management |  |  |
| 26 | 1.2.4.2 | Support on Smart Meters Act changes |  | 1089d | 2022-10-31 A | 2026-12-31 | 43% | 616d | 2022-10-31 | 2026-12-31 | 1089d | 2022-10-31 | 2026-12-31 | 255d |  |  | CPT |  | 5.0 | N/A | Green | GREEN | Programme Management |  |  |
| 27 | 1.2.4.3 | Support DCC/RECCo on CSS change |  | 1089d | 2022-10-31 A | 2026-12-31 | 43% | 616d | 2022-10-31 | 2026-12-31 | 1089d | 2022-10-31 | 2026-12-31 | 255d |  |  | CPT |  | 5.0 | N/A | Green | GREEN | Programme Management |  |  |
| 28 | 1.2.4.4 | Support Elexon on BSC change |  | 1089d | 2022-10-31 A | 2026-12-31 | 43% | 616d | 2022-10-31 | 2026-12-31 | 1089d | 2022-10-31 | 2026-12-31 | 255d |  |  | CPT |  | 5.0 | N/A | Green | GREEN | Programme Management |  |  |
| 29 | 1.2.4.5 | Support code change inside & outside CCIAG |  | 1089d | 2022-10-31 A | 2026-12-31 | 43% | 616d | 2022-10-31 | 2026-12-31 | 1089d | 2022-10-31 | 2026-12-31 | 255d |  |  | CPT |  | 5.0 | N/A | Green | GREEN | Programme Management |  |  |
| 30 | 1.2.4.6 | Support code change inside & outside CCAG |  | 1089d | 2022-10-31 A | 2026-12-31 | 43% | 616d | 2022-10-31 | 2026-12-31 | 1089d | 2022-10-31 | 2026-12-31 | 255d |  |  | CPT |  | 5.0 | N/A | Green | GREEN | Programme Management |  |  |

| ID | WBS | Task | Type | Duration | Start | Finish | Predecessors | Complete | Remaining | Baseline start | Baseline finish | Baseline duration | Baseline 1 start | Baseline 1 finish | Total slack | Constraint | Baseline cost | Responsible | Involved | Text9 | Task Status | Update Version | MHHS Resource Name | Sched Status | RAG | Text3 | MHHS Programme Phase | Artefact ID | Milestone ID | Text29 | Tier |
| --- | --- | --- | --- | --- | --- | --- | --- | --- | --- | --- | --- | --- | --- | --- | --- | --- | --- | --- | --- | --- | --- | --- | --- | --- | --- | --- | --- | --- | --- | --- | --- |
| 31 | 1.2.5 | **Programme Replan Baseline** |  | 163d | 2022-10-31 A | 2023-06-14 A |  | 100% |  | 2022-10-31 | 2023-06-14 | 163d | 2022-10-31 | 2023-06-14 |  |  |  | N/A | N/A | Programme Management | M5+ | 5.0 | N/A |  |  |  |  |  |  |  |  |
| 32 | 1.2.5.1 | Round 3 consultation preparation |  | 32d | 2022-10-31 A | 2022-12-13 A |  | 100% |  | 2022-10-31 | 2022-12-13 | 32d | 2022-10-31 | 2022-12-13 |  |  |  | PMO | CPT | Programme Management |  | 5.0 | N/A | Complete | COMPLETE |  |  |  |  |  |  |
| 33 | 1.2.5.2 | PSG decision to launch Round 3 consultation | milestone | 0d | 2022-12-07 A | 2022-12-07 A | 32FS-5d | 100% |  | 2022-12-07 | 2022-12-07 | 0d | 2022-12-07 | 2022-12-07 |  |  |  | PMO | PPC | Programme Management |  | 5.0 | N/A | Complete | COMPLETE |  |  |  |  |  |  |
| 34 | 1.2.5.3 | Round 3 consultation (incl. walkthroughs and Q&A) |  | 35d | 2022-12-14 A | 2023-01-31 A | 33FS+5d | 100% |  | 2022-12-14 | 2023-01-31 | 35d | 2022-12-14 | 2023-01-31 |  |  |  | PP | PMO, PPC,IPA | Programme Management |  | 5.0 | N/A | Complete | COMPLETE |  |  |  |  |  |  |
| 35 | 1.2.5.4 | Review and uplift of foundational testing documents to align with replan approach |  | 92d | 2022-12-14 A | 2023-04-20 A | 34SS | 100% |  | 2022-12-14 | 2023-04-20 | 92d | 2022-12-14 | 2023-04-20 |  |  |  | SI Test | CPT | Programme Management |  | 5.0 | N/A | Complete | COMPLETE |  |  |  |  |  |  |
| 36 | 1.2.5.5 | Round 3 consultation responses analysis (incl. identification of SIT volunteers) |  | 10d | 2023-02-01 A | 2023-02-14 A | 34 | 100% |  | 2023-02-01 | 2023-02-14 | 10d | 2023-02-01 | 2023-02-14 |  |  |  | PMO | CPT | Programme Management |  | 5.0 | N/A | Complete | COMPLETE |  |  |  |  |  |  |
| 37 | 1.2.5.6 | Replan re-drafting and supporting artefact updates (incl. engagement with Ofgem) |  | 26d | 2023-02-15 A | 2023-03-22 A | 36 | 100% |  | 2023-02-15 | 2023-03-22 | 26d | 2023-02-15 | 2023-03-22 |  |  |  | PMO | CPT,IPA,Ofgem | Programme Management |  | 5.0 | N/A | Complete | COMPLETE |  |  |  |  |  |  |
| 38 | 1.2.5.7 | Draft Replan Change Request |  | 31d | 2023-02-15 A | 2023-03-29 A | 36 | 100% |  | 2023-02-15 | 2023-03-29 | 31d | 2023-02-15 | 2023-03-29 |  |  |  | PMO | CPT | Programme Management |  | 5.0 | N/A | Complete | COMPLETE |  |  |  |  |  |  |
| 39 | 1.2.5.8 | PSG decision to issue CR for industry impact assessment | milestone | 0d | 2023-04-05 A | 2023-04-05 A | 38FS+5d | 100% |  | 2023-04-05 | 2023-04-05 | 0d | 2023-04-05 | 2023-04-05 |  |  |  | PMO | CPT | Programme Management |  | 5.0 | N/A | Complete | COMPLETE |  |  |  |  |  |  |
| 40 | 1.2.5.9 | Industry impact assessment |  | 10d | 2023-04-06 A | 2023-04-19 A | 39 | 100% |  | 2023-04-06 | 2023-04-19 | 10d | 2023-04-06 | 2023-04-19 |  |  |  | PP | PMO,PPC | Programme Management |  | 5.0 | N/A | Complete | COMPLETE |  |  |  |  |  |  |
| 41 | 1.2.5.10 | Replan playbacks (to assist PPs in impact assessment) |  | 5d | 2023-04-11 A | 2023-04-17 A | 40SS+3d | 100% |  | 2023-04-11 | 2023-04-17 | 5d | 2023-04-11 | 2023-04-17 |  |  |  | CPT | PPC,PP | Programme Management |  | 5.0 | N/A | Complete | COMPLETE |  |  |  |  |  |  |
| 42 | 1.2.5.11 | Industry impact assessment responses analysis |  | 5d | 2023-04-20 A | 2023-04-26 A | 40 | 100% |  | 2023-04-20 | 2023-04-26 | 5d | 2023-04-20 | 2023-04-26 |  |  |  | PMO | CPT | Programme Management |  | 5.0 | N/A | Complete | COMPLETE |  |  |  |  |  |  |
| 43 | 1.2.5.12 | Extraordinary PSG decision to agree baseline recommendation | milestone | 0d | 2023-05-03 A | 2023-05-03 A | 42FS+5d | 100% |  | 2023-05-03 | 2023-05-03 | 0d | 2023-05-03 | 2023-05-03 |  |  |  | CPT | PMO,PP | Programme Management |  | 5.0 | N/A | Complete | COMPLETE |  |  |  |  |  |  |
| 44 | 1.2.5.13 | Programme Replan playbacks and drop-in sessions |  | 5d | 2023-06-08 A | 2023-06-14 A |  | 100% |  | 2023-06-08 | 2023-06-14 | 5d | 2023-06-08 | 2023-06-14 |  |  |  | PMO | PPC, PP | Programme Management |  | 5.0 | N/A | Complete | COMPLETE |  |  |  |  |  |  |
| 45 | 1.3 | **DESIGN, BUILD & TEST (PIT)** |  | 1221d? | 2022-10-31 A | 2027-07-05 |  | 79% | 257.03d? | 2022-10-31 | 2027-07-05 | 1101d | 2022-10-31 | 2027-01-18 | 123d |  | -0 | N/A | N/A | DBT |  |  | N/A |  |  | 1 May 2022 - 31 Jul 2023 | Design, Build & Test (PIT) |  |  |  |  |
| 46 | 1.3.1 | **Design Baseline & Enduring PP Support** |  | 1101d | 2022-10-31 A | 2027-01-18 |  | 71% | 319.69d | 2022-10-31 | 2027-01-18 | 1101d | 2022-10-31 | 2027-01-18 | 243d |  | -0 | N/A | N/A | DBT |  | 5.0 | N/A |  |  |  | Design, Build & Test (PIT) |  |  |  |  |
| 47 | 1.3.1.1 | Physical design baselined (M5) | milestone | 0d | 2022-10-31 A | 2022-10-31 A |  | 100% |  | 2022-10-31 | 2022-10-31 | 0d | 2022-10-31 | 2022-10-31 |  |  |  | SRO Design | SI Design,PP,IPA | DBT |  | 5.0 | Paul Pettitt | Complete | COMPLETE |  | Design, Build & Test (PIT) | MHHS-ART001 | T1-DB-1000 | PSG | T1 |
| 48 | 1.3.1.2 | **M5 Design Work-Off Plan Implementation & Approval** |  | 79d | 2022-10-31 A | 2023-02-16 A |  | 100% |  | 2022-10-31 | 2023-02-16 | 79d | 2022-10-31 | 2023-02-16 |  |  |  | N/A | N/A | DBT |  | 5.0 | N/A |  |  |  | Design, Build & Test (PIT) |  |  |  |  |
| 49 | 1.3.1.2.1 | Implementation of M5 design Work-Off Plan |  | 74d | 2022-10-31 A | 2023-02-09 A | 47 | 100% |  | 2022-10-31 | 2023-02-09 | 74d | 2022-10-31 | 2023-02-09 |  |  |  | SI Design | PP | DBT |  | 5.0 | Paul Pettitt | Complete | COMPLETE |  | Design, Build & Test (PIT) |  |  |  |  |
| 50 | 1.3.1.2.2 | M5 design Work-Off Plan completion approved | milestone | 0d | 2023-02-16 A | 2023-02-16 A | 49FS+5d | 100% |  | 2023-02-16 | 2023-02-16 | 0d | 2023-02-16 | 2023-02-16 |  |  |  | SI Design | PP | DBT |  | 5.0 | Paul Pettitt | Complete | COMPLETE |  | Design, Build & Test (PIT) |  | T3-DB-0014 | DAG | T3 |
| 51 | 1.3.1.3 | **Enduring PP Design Support** |  | 1089d | 2022-10-31 A | 2026-12-31 A |  | 100% |  | 2022-10-31 | 2026-12-31 | 1089d | 2022-10-31 | 2026-12-31 |  |  |  | N/A | N/A | DBT |  | 5.0 | N/A |  |  |  | Design, Build & Test (PIT) |  |  |  |  |
| 52 | 1.3.1.3.1 | Design playbacks and drop-in sessions |  | 45d | 2022-10-31 A | 2022-12-30 A | 47 | 100% |  | 2022-10-31 | 2022-12-30 | 45d | 2022-10-31 | 2022-12-30 |  |  |  | SI Design | PMO,PPC, SRO Design | DBT |  | 5.0 | Paul Pettitt | Complete | COMPLETE |  | Design, Build & Test (PIT) |  |  |  |  |
| 53 | 1.3.1.3.2 | Support participants on E2E MHHS Design |  | 1089d | 2022-10-31 A | 2026-12-31 A | 47 | 100% |  | 2022-10-31 | 2026-12-31 | 1089d | 2022-10-31 | 2026-12-31 |  |  |  | SI Design | PP | DBT |  | 5.0 | Paul Pettitt | Complete | COMPLETE |  | Design, Build & Test (PIT) |  |  |  |  |
| 54 | 1.3.1.3.3 | DIP Onboarding Support |  | 70d | 2022-11-14 A | 2023-02-17 A |  | 100% |  | 2022-11-14 | 2023-02-17 | 70d | 2022-11-14 | 2023-02-17 |  | must start on 2022-11-14 |  | SI Design | SRO Design | DBT |  | 5.0 | Paul Pettitt | Complete | COMPLETE |  | Design, Build & Test (PIT) |  |  |  |  |
| 55 | 1.3.1.3.4 | iServer Launch | milestone | 0d | 2023-02-16 A | 2023-02-16 A | 50 | 100% |  | 2023-02-16 | 2023-02-16 | 0d | 2023-02-16 | 2023-02-16 |  |  |  | SI Design | PP | DBT |  | 5.0 | Paul Pettitt | Complete | COMPLETE |  | Design, Build & Test (PIT) |  |  |  |  |

| ID | WBS | Task | Type | Duration | Start | Finish | Predecessors | Complete | Remaining | Baseline start | Baseline finish | Baseline duration | Baseline 1 start | Baseline 1 finish | Total slack | Constraint | Baseline cost | Responsible | Involved | Text9 | Update Version | MHHS Resource Name | MHHS Programme Phase | Sched Status | RAG | Milestone ID | Text29 | Tier |
| --- | --- | --- | --- | --- | --- | --- | --- | --- | --- | --- | --- | --- | --- | --- | --- | --- | --- | --- | --- | --- | --- | --- | --- | --- | --- | --- | --- | --- |
| 56 | 1.3.1.4 | **Establish Design Change Management Processes** |  | 1101d | 2022-10-31 A | 2027-01-18 |  | 36% | 706.22d | 2022-10-31 | 2027-01-18 | 1101d | 2022-10-31 | 2027-01-18 | 243d |  |  | N/A | N/A | DBT | 5.0 | N/A | Design, Build & Test (PIT) |  |  |  |  |  |
| 57 | 1.3.1.4.1 | Internal review of internal change management processes |  | 35d | 2022-10-31 A | 2022-12-16 A |  | 100% |  | 2022-10-31 | 2022-12-16 | 35d | 2022-10-31 | 2022-12-16 |  |  |  | SRO | SI Design | DBT | 5.0 | Paul Pettitt | Design, Build & Test (PIT) | Complete | COMPLETE |  |  |  |
| 58 | 1.3.1.4.2 | SRO approval of internal change management processes | milestone | 0d | 2022-12-16 A | 2022-12-16 A | 57FF | 100% |  | 2022-12-16 | 2022-12-16 | 0d | 2022-12-16 | 2022-12-16 |  |  |  | SRO | SI Design | DBT | 5.0 | Paul Pettitt | Design, Build & Test (PIT) | Complete | COMPLETE |  |  |  |
| 59 | 1.3.1.4.3 | Change Process Webinar | milestone | 0d | 2023-01-16 A | 2023-01-16 A |  | 100% |  | 2023-01-16 | 2023-01-16 | 0d | 2023-01-16 | 2023-01-16 |  | must start on 2023-01-16 |  | SI Design | PP | DBT | 5.0 | Paul Pettitt | Design, Build & Test (PIT) | Complete | COMPLETE |  |  |  |
| 60 | 1.3.1.4.4 | Enduring change management process approved | milestone | 0d | 2023-02-16 A | 2023-02-16 A | 50FF | 100% |  | 2023-02-16 | 2023-02-16 | 0d | 2023-02-16 | 2023-02-16 |  |  |  | SI Design | PP | DBT | 5.0 | Paul Pettitt | Design, Build & Test (PIT) | Complete | COMPLETE | T3-DB-0016 | DAG | T3 |
| 61 | 1.3.1.4.5 | Maintain E2E MHHS Design (post-M5 design change management processes operational) |  | 1022d | 2023-02-17 A | 2027-01-18 | 60 | 34% | 678d | 2023-02-17 | 2027-01-18 | 1022d | 2023-02-17 | 2027-01-18 | 243d |  |  | SI Design | PP | DBT | 5.0 | Paul Pettitt | Design, Build & Test (PIT) | Green | GREEN |  |  |  |
| 62 | 1.3.1.5 | **Design Authority Mobilisation** |  | 29d | 2022-12-14 A | 2023-01-23 A |  | 100% |  | 2022-12-14 | 2023-01-23 | 29d | 2022-12-14 | 2023-01-23 |  |  |  | N/A | N/A | DBT | 5.0 | N/A | Design, Build & Test (PIT) |  |  |  |  |  |
| 63 | 1.3.1.5.1 | Design Authority ToR approved | milestone | 0d | 2022-12-14 A | 2022-12-14 A |  | 100% |  | 2022-12-14 | 2022-12-14 | 0d | 2022-12-14 | 2022-12-14 |  | must start on 2022-12-14 |  | SI Design | PP | DBT | 5.0 | Paul Pettitt | Design, Build & Test (PIT) | Complete | COMPLETE | T3-DB-0010 | DAG | T3 |
| 64 | 1.3.1.5.2 | Inaugural Design Authority | milestone | 0d | 2023-01-23 A | 2023-01-23 A | 63FS+29d | 100% |  | 2023-01-23 | 2023-01-23 | 0d | 2023-01-23 | 2023-01-23 |  |  |  | SI Design | PP | DBT | 5.0 | Paul Pettitt | Design, Build & Test (PIT) | Complete | COMPLETE |  |  |  |
| 65 | 1.3.1.6 | **Network Operation Services Adaptor Procurement** |  | 0d | 2023-05-23 A | 2023-05-23 A |  | 100% |  | 2023-05-23 | 2023-05-23 | 0d | 2023-02-01 | 2025-03-14 |  |  | -0 | N/A | N/A | DBT | 5.0 | N/A | Design, Build & Test (PIT) |  |  |  |  |  |
| 66 | 1.3.1.6.1 | All SIT LDSOs have procured their adapter providers | milestone | 0d | 2023-05-23 A | 2023-05-23 A | 585SS | 100% |  | 2023-05-23 | 2023-05-23 | 0d | 2023-05-23 | 2023-05-23 |  |  |  | SI Design | PP | DBT | 5.0 | Paul Pettitt | Design, Build & Test (PIT) | Complete | COMPLETE | T3-DB-0020 | DAG | T3 |
| 67 | 1.3.2 | **PP Mobilisation** |  | 67d | 2022-10-31 A | 2023-01-31 A |  | 100% |  | 2022-10-31 | 2023-01-31 | 67d | 2022-10-31 | 2023-01-31 |  |  |  | N/A | N/A | DBT | 5.0 | N/A | Design, Build & Test (PIT) |  |  |  |  |  |
| 68 | 1.3.2.1 | Set up governance |  | 67d | 2022-10-31 A | 2023-01-31 A |  | 100% |  | 2022-10-31 | 2023-01-31 | 67d | 2022-10-31 | 2023-01-31 |  |  |  | PP |  | DBT | 5.0 | PP | Design, Build & Test (PIT) | Complete | COMPLETE |  |  |  |
| 69 | 1.3.2.2 | Set up reporting |  | 67d | 2022-10-31 A | 2023-01-31 A |  | 100% |  | 2022-10-31 | 2023-01-31 | 67d | 2022-10-31 | 2023-01-31 |  |  |  | PP |  | DBT | 5.0 | PP | Design, Build & Test (PIT) | Complete | COMPLETE |  |  |  |
| 70 | 1.3.2.3 | Obtain funding |  | 67d | 2022-10-31 A | 2023-01-31 A |  | 100% |  | 2022-10-31 | 2023-01-31 | 67d | 2022-10-31 | 2023-01-31 |  |  |  | PP |  | DBT | 5.0 | PP | Design, Build & Test (PIT) | Complete | COMPLETE |  |  |  |
| 71 | 1.3.2.4 | Earmark resources |  | 67d | 2022-10-31 A | 2023-01-31 A |  | 100% |  | 2022-10-31 | 2023-01-31 | 67d | 2022-10-31 | 2023-01-31 |  |  |  | PP |  | DBT | 5.0 | PP | Design, Build & Test (PIT) | Complete | COMPLETE |  |  |  |
| 72 | 1.3.2.5 | Mobilise initial team |  | 67d | 2022-10-31 A | 2023-01-31 A |  | 100% |  | 2022-10-31 | 2023-01-31 | 67d | 2022-10-31 | 2023-01-31 |  |  |  | PP |  | DBT | 5.0 | PP | Design, Build & Test (PIT) | Complete | COMPLETE |  |  |  |
| 73 | 1.3.3 | **PIT Stub Specification and Delivery** |  | 435d | 2022-10-31 A | 2024-06-28 A |  | 100% |  | 2022-10-31 | 2024-06-28 | 430d | 2022-10-31 | 2023-05-31 |  |  | -0 | N/A | N/A | DBT | 5.0 | N/A | Design, Build & Test (PIT) |  |  |  |  |  |
| 74 | 1.3.3.1 | **DIP Simulator** |  | 108d | 2022-10-31 A | 2023-03-29 A |  | 100% |  | 2022-10-31 | 2023-03-29 | 108d | 2022-10-31 | 2023-03-29 |  |  |  | N/A | N/A | DBT | 5.0 | N/A | Design, Build & Test (PIT) |  |  |  |  |  |
| 75 | 1.3.3.1.1 | Build & Test |  | 95d | 2022-10-31 A | 2023-03-10 A | 47 | 100% |  | 2022-10-31 | 2023-03-10 | 95d | 2022-10-31 | 2023-03-10 |  |  |  | SI DevOps |  | DBT | 5.0 | Rebecca Farooq | Design, Build & Test (PIT) | Complete | COMPLETE |  |  |  |
| 76 | 1.3.3.1.2 | UAT |  | 85d | 2022-11-14 A | 2023-03-10 A | 75SS+10d | 100% |  | 2022-11-14 | 2023-03-10 | 85d | 2022-11-14 | 2023-03-10 |  |  |  | SI Test |  | DBT | 5.0 | Rebecca Farooq | Design, Build & Test (PIT) | Complete | COMPLETE |  |  |  |
| 77 | 1.3.3.1.3 | Beta test |  | 95d | 2022-10-31 A | 2023-03-10 A | 75SS | 100% |  | 2022-10-31 | 2023-03-10 | 95d | 2022-10-31 | 2023-03-10 |  |  |  | PP | SI Test | DBT | 5.0 | Rebecca Farooq | Design, Build & Test (PIT) | Complete | COMPLETE |  |  |  |
| 78 | 1.3.3.1.4 | Prepare for release |  | 18d | 2023-03-06 A | 2023-03-29 A | 77FS-5d | 100% |  | 2023-03-06 | 2023-03-29 | 18d | 2023-03-06 | 2023-03-29 |  |  |  | SI DevOps |  | DBT | 5.0 | Rebecca Farooq | Design, Build & Test (PIT) | Complete | COMPLETE |  |  |  |
| 79 | 1.3.3.1.5 | DIP Simulator released | milestone | 0d | 2023-03-29 A | 2023-03-29 A | 78FF | 100% |  | 2023-03-29 | 2023-03-29 | 0d | 2023-03-29 | 2023-03-29 |  | start no earlier than 2023-01-30 |  | SI DevOps |  | DBT | 5.0 | Rebecca Farooq | Design, Build & Test (PIT) | Complete | COMPLETE | T3-DB-0018 | SITAG | T3 |

| ID | WBS | Task | Type | Duration | Start | Finish | Predecessors | Complete | Remaining | Baseline start | Baseline finish | Baseline duration | Baseline 1 start | Baseline 1 finish | Total slack | Constraint | Baseline cost | Responsible | Involved | Text9 | Update Version | MHHS Resource Name | MHHS Programme Phase | Sched Status | RAG | Milestone ID | Text29 | Tier |
| --- | --- | --- | --- | --- | --- | --- | --- | --- | --- | --- | --- | --- | --- | --- | --- | --- | --- | --- | --- | --- | --- | --- | --- | --- | --- | --- | --- | --- |
| 80 | 1.3.3.2 | **DIP Simulator Uplifts** |  | 257d | 2023-07-06 A | 2024-06-28 A |  | 100% |  | 2023-07-06 | 2024-06-28 | 252d |  |  |  |  | -0 | N/A | N/A | DBT | 5.1 | N/A | Design, Build & Test (PIT) |  |  |  |  |  |
| 81 | 1.3.3.2.1 | DIP Simulator uplifted to align with design releases - design/build/test |  | 27d | 2023-07-06 A | 2023-08-11 A | 117 | 100% |  | 2023-07-06 | 2023-08-11 | 27d |  |  |  |  |  | SI DevOps |  | DBT | 5.1 | Rebecca Farooq | Design, Build & Test (PIT) | Complete | COMPLETE |  |  |  |
| 82 | 1.3.3.2.2 | DIP Simulator uplifted to align with Interim Release 2 | milestone | 0d | 2023-08-11 A | 2023-08-11 A | 81 | 100% |  | 2023-08-11 | 2023-08-11 | 0d |  |  |  |  |  | SI DevOps |  | DBT | 5.1 | Rebecca Farooq | Design, Build & Test (PIT) | Complete | COMPLETE | T3-DB-0035 | SITAG | T3 |
| 83 | 1.3.3.2.3 | DIP Simulator uplifted to align with design releases - design/build/test |  | 20d | 2023-10-09 A | 2023-11-03 A | 126FS+2d | 100% |  | 2023-10-09 | 2023-11-03 | 20d |  |  |  |  |  | SI DevOps |  | DBT | 5.3 | Rebecca Farooq | Design, Build & Test (PIT) | Complete | COMPLETE |  |  |  |
| 84 | 1.3.3.2.4 | DIP Simulator uplifted to align with Interim Release 5 | milestone | 0d | 2023-11-03 A | 2023-11-03 A | 83 | 100% |  | 2023-11-03 | 2023-11-03 | 0d |  |  |  |  |  | SI DevOps |  | DBT | 5.11 | Rebecca Farooq | Design, Build & Test (PIT) | Complete | COMPLETE | T3-DB-0039 | SITAG | T3 |
| 85 | 1.3.3.2.5 | DIP Simulator uplifted to align with design releases - design/build/test |  | 37d | 2024-02-01 A | 2024-03-22 A | 134 | 100% |  | 2024-02-01 | 2024-03-22 | 37d |  |  |  |  |  | SI DevOps | PP,SRO,Testing | DBT | 5.14 | Matthew Bray | Design, Build & Test (PIT) | Complete | COMPLETE |  |  |  |
| 86 | 1.3.3.2.6 | DIP Simulator uplifted to align with Interim Release 7 | milestone | 0d | 2024-03-22 A | 2024-03-22 A | 85 | 100% |  | 2024-03-22 | 2024-03-22 | 0d |  |  |  |  |  | SI DevOps | PP,SRO,Testing | DBT | 5.14 | Matthew Bray | Design, Build & Test (PIT) | Complete | COMPLETE | T3-DB-0182 | SITAG | T3 |
| 87 | 1.3.3.2.7 | DIP Simulator uplifted to align with design releases - design/build/test |  | 57d | 2024-04-04 A | 2024-06-21 A | 138 | 100% |  | 2024-04-04 | 2024-06-21 | 57d |  |  |  |  |  | SI DevOps | PP,SRO,Testing | DBT | 5.14 | Matthew Bray | Design, Build & Test (PIT) | Complete | COMPLETE |  |  |  |
| 88 | 1.3.3.2.8 | DIP Simulator uplifted to align with Interim Release 8 | milestone | 0d | 2024-06-28 A | 2024-06-28 A | 87FS+5d | 100% |  | 2024-06-28 | 2024-06-28 | 0d |  |  |  |  |  | SI DevOps | PP,SRO,Testing | DBT | 5.28 | Matthew Bray | Design, Build & Test (PIT) | Complete | COMPLETE | T3-DB-0183 | SITAG | T3 |
| 89 | 1.3.3.3 | **Data Generator** |  | 130d | 2022-12-01 A | 2023-05-31 A |  | 100% |  | 2022-12-01 | 2023-05-31 | 130d | 2022-12-01 | 2023-05-31 |  |  |  | N/A | N/A | DBT | 5.0 | N/A | Design, Build & Test (PIT) |  |  |  |  |  |
| 90 | 1.3.3.3.1 | Design | manual | 15d | 2022-12-01 A | 2022-12-21 A |  | 100% |  | 2022-12-01 | 2022-12-21 | 15d | 2022-12-01 | 2022-12-21 |  |  |  | SI DevOps |  | DBT | 5.0 | Rebecca Farooq | Design, Build & Test (PIT) | Complete | COMPLETE |  |  |  |
| 91 | 1.3.3.3.2 | Build & Test |  | 50d | 2023-02-16 A | 2023-04-26 A | 90FS+40d | 100% |  | 2023-02-16 | 2023-04-26 | 50d | 2023-02-16 | 2023-04-26 |  |  |  | SI DevOps |  | DBT | 5.0 | Rebecca Farooq | Design, Build & Test (PIT) | Complete | COMPLETE |  |  |  |
| 92 | 1.3.3.3.3 | UAT |  | 10d | 2023-04-27 A | 2023-05-10 A | 91 | 100% |  | 2023-04-27 | 2023-05-10 | 10d | 2023-04-27 | 2023-05-10 |  |  |  | SI Test |  | DBT | 5.0 | Rebecca Farooq | Design, Build & Test (PIT) | Complete | COMPLETE |  |  |  |
| 93 | 1.3.3.3.4 | Beta test |  | 45d | 2023-03-30 A | 2023-05-31 A | 91FS-20d, 95FF | 100% |  | 2023-03-30 | 2023-05-31 | 45d | 2023-03-30 | 2023-05-31 |  |  |  | PP | SI Test | DBT | 5.0 | Rebecca Farooq | Design, Build & Test (PIT) | Complete | COMPLETE |  |  |  |
| 94 | 1.3.3.3.5 | Prepare for release |  | 24d | 2023-04-27 A | 2023-05-30 A | 92SS | 100% |  | 2023-04-27 | 2023-05-30 | 24d | 2023-04-27 | 2023-05-30 |  |  |  | SI DevOps |  | DBT | 5.0 | Rebecca Farooq | Design, Build & Test (PIT) | Complete | COMPLETE |  |  |  |
| 95 | 1.3.3.3.6 | Data Generator released | milestone | 0d | 2023-05-31 A | 2023-05-31 A | 94FS+1d | 100% |  | 2023-05-31 | 2023-05-31 | 0d | 2023-05-31 | 2023-05-31 |  |  |  | SI DevOps |  | DBT | 5.0 | Rebecca Farooq | Design, Build & Test (PIT) | Complete | COMPLETE | T3-DB-0022 | SITAG | T3 |
| 96 | 1.3.4 | **Design Artefact Releases** |  | 466d | 2023-02-22 A | 2024-12-04 |  | 98% | 9.86d | 2023-02-22 | 2024-11-13 | 398d | 2023-02-22 | 2023-09-29 | 796d |  | -0 | N/A | N/A | DBT | 5.0 | N/A | Design, Build & Test (PIT) |  |  |  |  |  |
| 97 | 1.3.4.1 | **Interim release 1** |  | 79d | 2023-02-22 A | 2023-06-12 A |  | 100% |  | 2023-02-22 | 2023-06-12 | 79d | 2023-02-22 | 2023-06-28 |  |  |  | N/A | N/A | DBT | 5.0 | N/A | Design, Build & Test (PIT) |  |  |  |  |  |
| 98 | 1.3.4.1.1 | Prioritise DINs and CR |  | 1d | 2023-02-22 A | 2023-02-22 A |  | 100% |  | 2023-02-22 | 2023-02-22 | 1d | 2023-02-22 | 2023-02-22 |  | must start on 2023-02-22 |  | SI Design |  | DBT | 5.0 | Paul Pettitt | Design, Build & Test (PIT) | Complete | COMPLETE |  |  |  |
| 99 | 1.3.4.1.2 | **Industry input session** |  | 7d | 2023-02-23 A | 2023-03-03 A |  | 100% |  | 2023-02-23 | 2023-03-03 | 7d | 2023-02-23 | 2023-03-03 |  |  |  | N/A | N/A | DBT | 5.0 | N/A | Design, Build & Test (PIT) |  |  |  |  |  |
| 100 | 1.3.4.1.2.1 | Raise a CR covering prioritized assessment cluster |  | 1d | 2023-02-23 A | 2023-02-23 A | 98 | 100% |  | 2023-02-23 | 2023-02-23 | 1d | 2023-02-23 | 2023-02-23 |  |  |  | SI Design |  | DBT | 5.0 | Paul Pettitt | Design, Build & Test (PIT) | Complete | COMPLETE |  |  |  |
| 101 | 1.3.4.1.2.2 | Organize Industry Input session to go through significant items to reach consensus |  | 1d | 2023-02-23 A | 2023-02-23 A | 100SS | 100% |  | 2023-02-23 | 2023-02-23 | 1d | 2023-02-23 | 2023-02-23 |  |  |  | SI Design | PP | DBT | 5.0 | Paul Pettitt,Berlinda Kugara | Design, Build & Test (PIT) | Complete | COMPLETE |  |  |  |
| 102 | 1.3.4.1.2.3 | Conduct Meeting |  | 1d | 2023-03-03 A | 2023-03-03 A | 101FS+5d | 100% |  | 2023-03-03 | 2023-03-03 | 1d | 2023-03-03 | 2023-03-03 |  |  |  | SI Design | PP | DBT | 5.0 | Paul Pettitt,Berlinda Kugara | Design, Build & Test (PIT) | Complete | COMPLETE |  |  |  |
| 103 | 1.3.4.1.3 | Update baselined artefacts |  | 10d | 2023-03-24 A | 2023-04-06 A |  | 100% |  | 2023-03-24 | 2023-04-06 | 10d | 2023-03-24 | 2023-04-06 |  |  |  | SI Design |  | DBT | 5.0 | Paul Pettitt | Design, Build & Test (PIT) | Complete | COMPLETE |  |  |  |

Notes:
- 84: Action: 26/7/23 - forecast changed from 15/12/23 - 3/11/23 - Changed from Interim Release 6 to 5. Updated in milestone register

| ID | WBS | Task | Type | Duration | Start | Finish | Predecessors | Complete | Baseline start | Baseline finish | Baseline duration | Baseline 1 start | Baseline 1 finish | Constraint | Baseline cost | Responsible | Involved | Text9 | Update Version | MHHS Resource Name | MHHS Programme Phase | Sched Status | RAG | Milestone ID | Text29 | Tier | Action |
| --- | --- | --- | --- | --- | --- | --- | --- | --- | --- | --- | --- | --- | --- | --- | --- | --- | --- | --- | --- | --- | --- | --- | --- | --- | --- | --- | --- |
| 104 | 1.3.4.1.4 | **Participant review and impact assess changes** |  | 18d | 2023-04-14 A | 2023-05-09 A |  | 100% | 2023-04-14 | 2023-05-09 | 18d | 2023-04-14 | 2023-05-09 |  |  | N/A | N/A | DBT | 5.0 | N/A | Design, Build & Test (PIT) |  |  |  |  |  |  |
| 105 | 1.3.4.1.4.1 | Issue Redline Version of documents |  | 1d | 2023-04-14 A | 2023-04-14 A | 103FS+5d | 100% | 2023-04-14 | 2023-04-14 | 1d | 2023-04-14 | 2023-04-14 |  |  | SI Design |  | DBT | 5.0 | Paul Pettitt | Design, Build & Test (PIT) | Complete | COMPLETE |  |  |  |  |
| 106 | 1.3.4.1.4.2 | Participants provide review comments to common log |  | 17d | 2023-04-17 A | 2023-05-09 A | 105 | 100% | 2023-04-17 | 2023-05-09 | 17d | 2023-04-17 | 2023-05-09 |  |  | PP |  | DBT | 5.0 | Paul Pettitt | Design, Build & Test (PIT) | Complete | COMPLETE |  |  |  |  |
| 107 | 1.3.4.1.5 | **Assurance review** |  | 19d | 2023-05-10 A | 2023-06-05 A |  | 100% | 2023-05-10 | 2023-06-05 | 19d | 2023-05-10 | 2023-06-05 |  |  | N/A | N/A | DBT | 5.0 | N/A | Design, Build & Test (PIT) |  |  |  |  |  |  |
| 108 | 1.3.4.1.5.1 | SI Design Review and Respond to Comments |  | 5d | 2023-05-10 A | 2023-05-16 A | 106 | 100% | 2023-05-10 | 2023-05-16 | 5d | 2023-05-10 | 2023-05-16 |  |  | SI Design |  | DBT | 5.0 | Paul Pettitt | Design, Build & Test (PIT) | Complete | COMPLETE |  |  |  |  |
| 109 | 1.3.4.1.5.2 | Prep for Assurance Review Meeting |  | 7d | 2023-05-17 A | 2023-05-25 A | 108 | 100% | 2023-05-17 | 2023-05-25 | 7d | 2023-05-17 | 2023-05-25 |  |  | SI Design |  | DBT | 5.0 | Paul Pettitt | Design, Build & Test (PIT) | Complete | COMPLETE |  |  |  |  |
| 110 | 1.3.4.1.5.3 | Conduct Assurance Review Meeting |  | 1d | 2023-05-26 A | 2023-05-26 A | 109 | 100% | 2023-05-26 | 2023-05-26 | 1d | 2023-05-26 | 2023-05-26 |  |  | SI Design |  | DBT | 5.0 | Paul Pettitt | Design, Build & Test (PIT) | Complete | COMPLETE |  |  |  |  |
| 111 | 1.3.4.1.5.4 | Update Artefacts following Assurance Review |  | 6d | 2023-05-29 A | 2023-06-05 A | 110 | 100% | 2023-05-29 | 2023-06-05 | 6d | 2023-05-29 | 2023-06-05 |  |  | SI Design |  | DBT | 5.0 | Paul Pettitt | Design, Build & Test (PIT) | Complete | COMPLETE |  |  |  |  |
| 112 | 1.3.4.1.6 | PSG Approval of interim release plan |  | 1d | 2023-06-08 A | 2023-06-08 A |  | 100% | 2023-06-08 | 2023-06-08 | 1d |  |  | must start on 2023-06-08 |  | PP | SI Design | DBT | 5.1 | Paul Pettitt | Design, Build & Test (PIT) | Complete | COMPLETE |  |  |  |  |
| 113 | 1.3.4.1.7 | Publish updated baselined artefacts | milestone | 0d | 2023-06-06 A | 2023-06-12 A | 111 | 100% | 2023-06-06 | 2023-06-12 | 5d | 2023-06-15 | 2023-06-21 |  |  | SI Design |  | DBT | 5.0 | Paul Pettitt | Design, Build & Test (PIT) | Complete | COMPLETE |  |  |  |  |
| 114 | 1.3.4.1.8 | Interim release 1 Go live | milestone | 0d | 2023-06-12 A | 2023-06-12 A | 113 | 100% | 2023-06-12 | 2023-06-12 | 0d | 2023-06-28 | 2023-06-28 |  |  | SI Design |  | DBT | 5.0 | Paul Pettitt | Design, Build & Test (PIT) | Complete | COMPLETE | T3-DB-0095 | DAG | T3 |  |
| 115 | 1.3.4.2 | **Interim release 2** |  | 27d | 2023-05-30 A | 2023-07-05 A |  | 100% | 2023-05-30 | 2023-07-05 | 27d | 2023-05-24 | 2023-07-28 |  |  | N/A | N/A | DBT | 5.0 | N/A | Design, Build & Test (PIT) |  |  |  |  |  |  |
| 116 | 1.3.4.2.1 | Update baselined artefacts |  | 27d | 2023-05-30 A | 2023-07-05 A |  | 100% | 2023-05-30 | 2023-07-05 | 27d |  |  | must start on 2023-05-30 |  | SI Design | PP | DBT | 5.1 | Paul Pettitt | Design, Build & Test (PIT) | Complete | COMPLETE |  |  |  |  |
| 117 | 1.3.4.2.2 | Interim release 2 Go live | milestone | 0d | 2023-07-05 A | 2023-07-05 A | 116 | 100% | 2023-07-05 | 2023-07-05 | 0d | 2023-07-28 | 2023-07-28 |  |  | SI Design |  | DBT | 5.0 | Paul Pettitt | Design, Build & Test (PIT) | Complete | COMPLETE | T3-DB-0096 | DAG | T3 |  |
| 118 | 1.3.4.3 | **Interim release 3** |  | 35d | 2023-06-15 A | 2023-08-02 A |  | 100% | 2023-06-15 | 2023-08-02 | 35d | 2023-06-29 | 2023-09-29 |  |  | N/A | N/A | DBT | 5.0 | N/A | Design, Build & Test (PIT) |  |  |  |  |  |  |
| 119 | 1.3.4.3.1 | Update baselined artefacts |  | 35d | 2023-06-15 A | 2023-08-02 A |  | 100% | 2023-06-15 | 2023-08-02 | 35d |  |  | must start on 2023-06-15 |  | SI Design | PP | DBT | 5.1 | Paul Pettitt | Design, Build & Test (PIT) | Complete | COMPLETE |  |  |  |  |
| 120 | 1.3.4.3.2 | Interim release 3 Go live | milestone | 0d | 2023-08-02 A | 2023-08-02 A | 119 | 100% | 2023-08-02 | 2023-08-02 | 0d | 2023-09-29 | 2023-09-29 |  |  | SI Design |  | DBT | 5.0 | Paul Pettitt | Design, Build & Test (PIT) | Complete | COMPLETE | T3-DB-0097 | DAG | T3 |  |
| 121 | 1.3.4.4 | **Interim release 4** |  | 36d | 2023-07-12 A | 2023-08-30 A |  | 100% | 2023-07-12 | 2023-08-30 | 36d |  |  |  |  | N/A | N/A | DBT | 5.1 | N/A | Design, Build & Test (PIT) |  |  |  |  |  |  |
| 122 | 1.3.4.4.1 | Update baselined artefacts |  | 36d | 2023-07-12 A | 2023-08-30 A |  | 100% | 2023-07-12 | 2023-08-30 | 36d |  |  | must start on 2023-07-12 |  | SI Design | PP | DBT | 5.1 | Paul Pettitt | Design, Build & Test (PIT) | Complete | COMPLETE |  |  |  |  |
| 123 | 1.3.4.4.2 | Interim release 4 Go live | milestone | 0d | 2023-08-30 A | 2023-08-30 A | 122 | 100% | 2023-08-30 | 2023-08-30 | 0d |  |  |  |  | SI Design |  | DBT | 5.1 | Paul Pettitt | Design, Build & Test (PIT) | Complete | COMPLETE | T3-DB-0081 | DAG | T3 |  |
| 124 | 1.3.4.5 | **Interim release 5** |  | 147d | 2023-08-17 A | 2024-03-08 A |  | 100% | 2023-08-17 | 2024-03-08 | 147d |  |  |  | -0 | N/A | N/A | DBT | 5.1 | N/A | Design, Build & Test (PIT) |  |  |  |  |  |  |
| 125 | 1.3.4.5.1 | Update baselined artefacts |  | 35d | 2023-08-17 A | 2023-10-04 A |  | 100% | 2023-08-17 | 2023-10-04 | 35d |  |  | must start on 2023-08-17 |  | SI Design | PP | DBT | 5.1 | Paul Pettitt | Design, Build & Test (PIT) | Complete | COMPLETE |  |  |  |  |
| 126 | 1.3.4.5.2 | Interim release 5 Go live | milestone | 0d | 2023-10-04 A | 2023-10-04 A | 125 | 100% | 2023-10-04 | 2023-10-04 | 0d |  |  |  |  | SI Design |  | DBT | 5.1 | Paul Pettitt | Design, Build & Test (PIT) | Complete | COMPLETE | T3-DB-0083 | DAG | T3 | 11/8 - successor is SIT functional (starts in march) |
| 127 | 1.3.4.5.3 | Interim Release 5 Deployed to SIT |  | 10d | 2024-02-26 A | 2024-03-08 A | 126FS+102d | 100% | 2024-02-26 | 2024-03-08 | 10d |  |  |  |  | SI Testing | PP | DBT | 5.16 |  |  | Complete | COMPLETE |  |  |  |  |

| ID | WBS | Task | Type | Duration | Start | Finish | Predecessors | Complete | Remaining | Baseline start | Baseline finish | Baseline duration | Baseline 1 start | Baseline 1 finish | Total slack | Free slack | Constraint | Baseline cost | Responsible | Involved | Text9 | Update Version | MHHS Resource Name | MHHS Programme Phase | Sched Status | RAG | Milestone ID | Text29 | Tier | Action | Task Status |
| --- | --- | --- | --- | --- | --- | --- | --- | --- | --- | --- | --- | --- | --- | --- | --- | --- | --- | --- | --- | --- | --- | --- | --- | --- | --- | --- | --- | --- | --- | --- | --- |
| 128 | 1.3.4.6 | **Interim release 6** |  | 192d | 2023-09-14 A | 2024-06-07 A |  | 100% |  | 2023-09-14 | 2024-06-07 | 192d |  |  |  |  |  | -0 | N/A | N/A | DBT | 5.1 | N/A | Design, Build & Test (PIT) |  |  |  |  |  |  |  |
| 129 | 1.3.4.6.1 | Update baselined artefacts |  | 35d | 2023-09-14 A | 2023-11-01 A |  | 100% |  | 2023-09-14 | 2023-11-01 | 32d |  |  |  |  | must start on 2023-09-14 |  | SI Design | PP | DBT | 5.1 | Paul Pettitt | Design, Build & Test (PIT) | Complete | COMPLETE |  |  |  |  |  |
| 130 | 1.3.4.6.2 | Interim release 6 Go live | milestone | 0d | 2023-11-01 A | 2023-11-01 A | 129 | 100% |  | 2023-11-01 | 2023-11-01 | 0d |  |  |  |  |  |  | SI Design |  | DBT | 5.11 | Paul Pettitt | Design, Build & Test (PIT) | Complete | COMPLETE | T3-DB-0085 | DAG | T3 |  |  |
| 131 | 1.3.4.6.3 | Interim Release 6 Deployed to SIT |  | 10d | 2024-05-27 A | 2024-06-07 A | 130FS+147d | 100% |  | 2024-05-27 | 2024-06-07 | 10d |  |  |  |  |  |  | SI Testing | PP | DBT | 5.16 |  |  | Complete | COMPLETE |  |  |  |  |  |
| 132 | 1.3.4.7 | **Interim release 7** |  | 168d | 2023-10-18 A | 2024-06-07 A |  | 100% |  | 2023-10-18 | 2024-06-07 | 168d |  |  |  |  |  | -0 | N/A | N/A | DBT | 5.5 | N/A | Design, Build & Test (PIT) |  |  |  |  |  |  |  |
| 133 | 1.3.4.7.1 | Update baselined artefacts |  | 76d | 2023-10-18 A | 2024-01-31 A |  | 100% |  | 2023-10-18 | 2024-01-31 | 76d |  |  |  |  | start no earlier than 2023-10-18 |  | SI Design | PP | DBT | 5.5 | Paul Pettitt | Design, Build & Test (PIT) | Complete | COMPLETE |  |  |  |  |  |
| 134 | 1.3.4.7.2 | Interim release 7 Go live | milestone | 0d | 2024-01-31 A | 2024-01-31 A | 133 | 100% |  | 2024-01-31 | 2024-01-31 | 0d |  |  |  |  |  |  | SI Design | PP | DBT | 5.14 | Paul Pettitt | Design, Build & Test (PIT) | Complete | COMPLETE | T3-DB-0098 | DAG | T3 | 4/8 - add as t3 milestones. Awaiting approval at TMAG |  |
| 135 | 1.3.4.7.3 | Interim Release 7 Deployed to SIT |  | 10d | 2024-05-27 A | 2024-06-07 A | 134FS+82d | 100% |  | 2024-05-27 | 2024-06-07 | 10d |  |  |  |  |  |  | SI Testing | PP | DBT | 5.16 |  |  | Complete | COMPLETE |  |  |  |  |  |
| 136 | 1.3.4.8 | **Interim release 8** |  | 211d | 2024-02-14 A | 2024-12-04 |  | 85% | 32.46d | 2024-02-14 | 2024-11-13 | 143d |  |  | 796d |  |  | -0 | N/A | N/A | DBT | 5.5 | N/A | Design, Build & Test (PIT) |  |  |  |  |  |  |  |
| 137 | 1.3.4.8.1 | Update baselined artefacts |  | 36d | 2024-02-14 A | 2024-04-03 A |  | 100% |  | 2024-02-14 | 2024-04-03 | 36d |  |  |  |  | start no earlier than 2024-02-14 |  | SI Design | PP | DBT | 5.5 | Paul Pettitt | Design, Build & Test (PIT) | Complete | COMPLETE |  |  |  |  |  |
| 138 | 1.3.4.8.2 | Interim release 8 Go live | milestone | 0d | 2024-04-03 A | 2024-04-03 A | 137 | 100% |  | 2024-04-03 | 2024-04-03 | 0d |  |  |  |  | start no earlier than 2024-01-10 |  | SI Design | PP | DBT | 5.14 | Paul Pettitt | Design, Build & Test (PIT) | Complete | COMPLETE | T3-DB-0099 | DAG | T3 | 4/8 - add as t3 milestones. Awaiting approval at TMAG |  |
| 139 | 1.3.4.8.3 | **Interim Release 8.3 - Maintenance Window** |  | 11d | 2024-10-07 A | 2024-10-21 A |  | 100% |  | 2024-10-07 | 2024-10-21 | 0d |  |  |  |  |  |  | Design |  | DBT | 6.0 |  |  | Overdue Start |  |  |  |  |  | -686.67 |
| 140 | 1.3.4.8.3.1 | Interim Release 8.3 'effective from date' to SIT A | milestone | 0d | 2024-10-21 A | 2024-10-21 A | 138FS+143d | 100% |  | 2024-10-21 | 2024-10-21 | 10d |  |  |  |  |  |  | SI Testing | PP | DBT | 5.16 | Roger Robar |  | Complete | COMPLETE |  |  |  |  |  |
| 141 | 1.3.4.8.3.2 | Interim Release 8.3 'effective from date' to SIT B | milestone | 0d | 2024-10-07 A | 2024-10-07 A | 140SS-11d | 100% |  | 2024-10-07 | 2024-10-07 | 0d |  |  |  |  |  |  | Design |  | DBT | 5.16 |  |  | Complete | COMPLETE |  |  |  |  |  |
| 142 | 1.3.4.8.4 | **Interim Release 8.4** |  | 36d | 2024-09-25 A | 2024-11-13 |  | 99% | 0d | 2024-09-25 | 2024-11-13 | 0d |  |  | 811d |  |  |  | Design |  | DBT | 6.1 |  |  | Overdue Start |  | T3-DB-0184 |  |  |  | -694.67 |
| 143 | 1.3.4.8.4.1 | Update baselined artefacts |  | 8d | 2024-09-25 A | 2024-10-04 A |  | 100% |  | 2024-09-25 | 2024-10-04 | 0d |  |  |  |  | start no earlier than 2024-09-25 |  | Design |  | DBT | 6.1 |  |  | Complete | COMPLETE |  |  |  |  |  |
| 144 | 1.3.4.8.4.2 | Interim release 8.4 Published | milestone | 0d | 2024-10-16 A | 2024-10-16 A | 143FS+8d | 100% |  | 2024-10-16 | 2024-10-16 | 0d |  |  |  |  | start no earlier than 2024-10-09 |  | Design |  | DBT | 6.1 |  |  | Complete | COMPLETE |  |  |  |  |  |
| 145 | 1.3.4.8.4.3 | Interim Release 8.4 Deployed to SIT by Participants | milestone | 0d | 2024-11-13 A | 2024-11-13 | 144FS+20d | 80% | 0d | 2024-11-13 | 2024-11-13 | 0d |  |  | 811d |  |  |  | Design |  | DBT | 6.1 |  |  | Green | GREEN |  |  |  |  |  |
| 146 | 1.3.4.8.5 | **Interim Release 8.5** |  | 36d | 2024-10-16 | 2024-12-04 |  |  |  | 2024-10-16 | 2024-12-04 |  |  |  | 796d |  |  |  |  |  | DBT | 6.11 |  |  | Overdue Start |  | T3-DB-0185 |  |  |  | -728.67 |
| 147 | 1.3.4.8.5.1 | Update baselined artefacts |  | 8d | 2024-10-16 | 2024-10-25 |  |  |  | 2024-10-16 | 2024-10-25 |  |  |  | 796d | 0d | start no earlier than 2024-10-16 |  |  |  | DBT | 6.11 |  |  | Overdue Start | GREEN |  |  |  |  | -14.67 |
| 148 | 1.3.4.8.5.2 | Interim release 8.5 Published | milestone | 0d | 2024-11-06 | 2024-11-06 | 147FS+8d |  |  | 2024-11-06 | 2024-11-06 |  |  |  | 796d | 0d |  |  |  |  | DBT | 6.11 |  |  | Green | GREEN |  |  |  |  | 6.71 |
| 149 | 1.3.4.8.5.3 | Interim Release 8.5 Deployed to SIT by Participants | milestone | 0d | 2024-12-04 | 2024-12-04 | 148FS+20d |  |  | 2024-12-04 | 2024-12-04 |  |  |  | 796d |  |  |  |  |  | DBT | 6.11 |  |  | Green | GREEN |  |  |  |  | 34.71 |
| 150 | 1.3.5 | **Queries Support / Knowledgebase & Tool Roll-Out (Systems)** |  | 325d | 2023-01-03 A | 2024-04-01 A |  | 100% |  | 2023-01-03 | 2024-04-01 | 325d | 2023-01-03 | 2024-04-01 |  |  |  |  | N/A | N/A | DBT | 5.0 | N/A | Design, Build & Test (PIT) |  |  |  |  |  |  |  |
| 151 | 1.3.5.1 | **Query Management** |  | 325d | 2023-01-03 A | 2024-04-01 A |  | 100% |  | 2023-01-03 | 2024-04-01 | 325d | 2023-01-03 | 2024-04-01 |  |  |  |  | N/A | N/A | DBT | 5.0 | N/A | Design, Build & Test (PIT) |  |  |  |  |  |  |  |
| 152 | 1.3.5.1.1 | Respond to Participant Queries |  | 325d | 2023-01-03 A | 2024-04-01 A |  | 100% |  | 2023-01-03 | 2024-04-01 | 325d | 2023-01-03 | 2024-04-01 |  |  | must start on 2023-01-03 |  | SI Design | PP | DBT | 5.0 | Paul Pettitt | Design, Build & Test (PIT) | Complete | COMPLETE |  |  |  | 11/8 - runs out to end of the programme |  |
| 153 | 1.3.5.1.2 | Respond to Programme Queries |  | 325d | 2023-01-03 A | 2024-04-01 A | 152SS | 100% |  | 2023-01-03 | 2024-04-01 | 325d | 2023-01-03 | 2024-04-01 |  |  |  |  | SI Design | PP | DBT | 5.0 | Paul Pettitt | Design, Build & Test (PIT) | Complete | COMPLETE |  |  |  | 11/8 - runs out to end of the programme |  |

| ID | WBS | Task | Duration | Start | Finish | Predecessors | Complete | Remaining | Baseline start | Baseline finish | Baseline duration | Baseline 1 start | Baseline 1 finish | Total slack | Constraint | Baseline cost | Responsible | Involved | Text9 | Update Version | MHHS Resource Name | MHHS Programme Phase | Sched Status | RAG |
| --- | --- | --- | --- | --- | --- | --- | --- | --- | --- | --- | --- | --- | --- | --- | --- | --- | --- | --- | --- | --- | --- | --- | --- | --- |
| 154 | 1.3.5.2 | **Query Support tooling (FreshDesk)** | 23d | 2023-06-01 A | 2023-07-03 A |  | 100% |  | 2023-06-01 | 2023-07-03 | 23d | 2023-06-01 | 2023-07-03 |  |  |  | N/A | N/A | DBT | 5.0 | N/A | Design, Build & Test (PIT) |  |  |
| 155 | 1.3.5.2.1 | Migrate to Standalone Freshdesk | 10d | 2023-06-01 A | 2023-06-14 A |  | 100% |  | 2023-06-01 | 2023-06-14 | 10d | 2023-06-01 | 2023-06-14 |  | must start on 2023-06-01 |  | SI Design |  | DBT | 5.0 | Paul Pettitt | Design, Build & Test (PIT) | Complete | COMPLETE |
| 156 | 1.3.5.2.2 | Develop reporting dashboard | 5d | 2023-06-15 A | 2023-06-21 A | 155 | 100% |  | 2023-06-15 | 2023-06-21 | 5d | 2023-06-15 | 2023-06-21 |  |  |  | SI Design |  | DBT | 5.0 | Paul Pettitt | Design, Build & Test (PIT) | Complete | COMPLETE |
| 157 | 1.3.5.2.3 | Issue to SRO for Review | 5d | 2023-06-22 A | 2023-06-28 A | 156 | 100% |  | 2023-06-22 | 2023-06-28 | 5d | 2023-06-22 | 2023-06-28 |  |  |  | SI Design |  | DBT | 5.0 | Paul Pettitt | Design, Build & Test (PIT) | Complete | COMPLETE |
| 158 | 1.3.5.2.4 | Update following review | 2d | 2023-06-29 A | 2023-06-30 A | 157 | 100% |  | 2023-06-29 | 2023-06-30 | 2d | 2023-06-29 | 2023-06-30 |  |  |  | SI Design |  | DBT | 5.0 | Paul Pettitt | Design, Build & Test (PIT) | Complete | COMPLETE |
| 159 | 1.3.5.2.5 | Sign off | 1d | 2023-07-03 A | 2023-07-03 A | 158 | 100% |  | 2023-07-03 | 2023-07-03 | 1d | 2023-07-03 | 2023-07-03 |  |  |  | SI Design |  | DBT | 5.0 | Paul Pettitt | Design, Build & Test (PIT) | Complete | COMPLETE |
| 160 | 1.3.5.3 | **KnowledgeBase Development** | 72d | 2023-06-01 A | 2023-09-08 A |  | 100% |  | 2023-06-01 | 2023-09-08 | 72d | 2023-06-01 | 2023-09-08 |  |  |  | N/A | N/A | DBT | 5.0 | N/A | Design, Build & Test (PIT) |  |  |
| 161 | 1.3.5.3.1 | Define Scope of KB | 1d | 2023-06-01 A | 2023-06-01 A | 155SS | 100% |  | 2023-06-01 | 2023-06-01 | 1d | 2023-06-01 | 2023-06-01 |  |  |  | SI Design |  | DBT | 5.0 | Paul Pettitt | Design, Build & Test (PIT) | Complete | COMPLETE |
| 162 | 1.3.5.3.2 | Capture Existing KB artefacts | 20d | 2023-06-02 A | 2023-06-29 A | 161 | 100% |  | 2023-06-02 | 2023-06-29 | 20d | 2023-06-02 | 2023-06-29 |  |  |  | SI Design |  | DBT | 5.0 | Paul Pettitt | Design, Build & Test (PIT) | Complete | COMPLETE |
| 163 | 1.3.5.3.3 | Tag artefacts | 5d | 2023-06-30 A | 2023-07-06 A | 162 | 100% |  | 2023-06-30 | 2023-07-06 | 5d | 2023-06-30 | 2023-07-06 |  |  |  | SI Design |  | DBT | 5.0 | Paul Pettitt | Design, Build & Test (PIT) | Complete | COMPLETE |
| 164 | 1.3.5.3.4 | Develop Participant Interfaces | 20d | 2023-07-07 A | 2023-08-03 A | 163 | 100% |  | 2023-07-07 | 2023-08-03 | 20d | 2023-07-07 | 2023-08-03 |  |  |  | SI Design |  | DBT | 5.0 | Paul Pettitt | Design, Build & Test (PIT) | Complete | COMPLETE |
| 165 | 1.3.5.3.5 | Promote to Collaboration Portal | 21d | 2023-08-04 A | 2023-09-01 A | 164 | 100% |  | 2023-08-04 | 2023-09-01 | 21d | 2023-08-04 | 2023-09-01 |  |  |  | SI Design |  | DBT | 5.0 | Paul Pettitt | Design, Build & Test (PIT) | Complete | COMPLETE |
| 166 | 1.3.5.3.6 | Link into FreshDesk | 5d | 2023-09-04 A | 2023-09-08 A | 165 | 100% |  | 2023-09-04 | 2023-09-08 | 5d | 2023-09-04 | 2023-09-08 |  |  |  | SI Design |  | DBT | 5.0 | Paul Pettitt | Design, Build & Test (PIT) | Complete | COMPLETE |
| 167 | 1.3.6 | **PP Design, Build & Test (DBT)** | 1221d? | 2022-10-31 A | 2027-07-05 |  | 82% | 216.25d? | 2022-10-31 | 2027-07-05 | 495d | 2022-10-31 | 2026-02-16 | 123d |  | -0 | N/A | N/A | DBT | 5.0 | N/A | Design, Build & Test (PIT) |  |  |
| 168 | 1.3.6.1 | **PP Impact Assessment, Planning & Procurement** | 110d | 2022-10-31 A | 2023-03-31 A |  | 100% |  | 2022-10-31 | 2023-03-31 | 110d | 2022-10-31 | 2023-03-31 |  |  |  | N/A | N/A | DBT | 5.0 | N/A | Design, Build & Test (PIT) |  |  |
| 169 | 1.3.6.1.1 | **PP Impact Assessment** | 67d | 2022-10-31 A | 2023-01-31 A |  | 100% |  | 2022-10-31 | 2023-01-31 | 67d | 2022-10-31 | 2023-01-31 |  |  |  | N/A | N/A | DBT | 5.0 | N/A | Design, Build & Test (PIT) |  |  |
| 170 | 1.3.6.1.1.1 | Develop heatmap for impact of MHHS | 67d | 2022-10-31 A | 2023-01-31 A | 47 | 100% |  | 2022-10-31 | 2023-01-31 | 67d | 2022-10-31 | 2023-01-31 |  |  |  | PP |  | DBT | 5.0 | PP | Design, Build & Test (PIT) | Complete | COMPLETE |
| 171 | 1.3.6.1.1.2 | Develop detailed impact assessment | 67d | 2022-10-31 A | 2023-01-31 A | 47 | 100% |  | 2022-10-31 | 2023-01-31 | 67d | 2022-10-31 | 2023-01-31 |  |  |  | PP |  | DBT | 5.0 | PP | Design, Build & Test (PIT) | Complete | COMPLETE |
| 172 | 1.3.6.1.2 | **PP Planning** | 67d | 2022-10-31 A | 2023-01-31 A |  | 100% |  | 2022-10-31 | 2023-01-31 | 67d | 2022-10-31 | 2023-01-31 |  |  |  | N/A | N/A | DBT | 5.0 | N/A | Design, Build & Test (PIT) |  |  |
| 173 | 1.3.6.1.2.1 | Develop detailed short-term plan | 23d | 2022-10-31 A | 2022-11-30 A | 47 | 100% |  | 2022-10-31 | 2022-11-30 | 23d | 2022-10-31 | 2022-11-30 |  |  |  | PP |  | DBT | 5.0 | PP | Design, Build & Test (PIT) | Complete | COMPLETE |
| 174 | 1.3.6.1.2.2 | Develop overall project plan for implementation | 67d | 2022-10-31 A | 2023-01-31 A | 47 | 100% |  | 2022-10-31 | 2023-01-31 | 67d | 2022-10-31 | 2023-01-31 |  |  |  | PP |  | DBT | 5.0 | PP | Design, Build & Test (PIT) | Complete | COMPLETE |
| 175 | 1.3.6.1.2.3 | Develop procurement plan | 67d | 2022-10-31 A | 2023-01-31 A | 47 | 100% |  | 2022-10-31 | 2023-01-31 | 67d | 2022-10-31 | 2023-01-31 |  |  |  | PP |  | DBT | 5.0 | PP | Design, Build & Test (PIT) | Complete | COMPLETE |
| 176 | 1.3.6.1.3 | **PP Software/Service Procurement** | 110d | 2022-10-31 A | 2023-03-31 A |  | 100% |  | 2022-10-31 | 2023-03-31 | 110d | 2022-10-31 | 2023-03-31 |  |  |  | N/A | N/A | DBT | 5.0 | N/A | Design, Build & Test (PIT) |  |  |
| 177 | 1.3.6.1.3.1 | Run tender process | 67d | 2022-10-31 A | 2023-01-31 A | 47 | 100% |  | 2022-10-31 | 2023-01-31 | 67d | 2022-10-31 | 2023-01-31 |  |  |  | PP |  | DBT | 5.0 | PP | Design, Build & Test (PIT) | Complete | COMPLETE |
| 178 | 1.3.6.1.3.2 | Select provider & sign commercials | 43d | 2023-02-01 A | 2023-03-31 A | 177 | 100% |  | 2023-02-01 | 2023-03-31 | 43d | 2023-02-01 | 2023-03-31 |  |  |  | PP |  | DBT | 5.0 | PP | Design, Build & Test (PIT) | Complete | COMPLETE |

| ID | WBS | Task | Duration | Start | Finish | Predecessors | Complete | Remaining | Baseline start | Baseline finish | Baseline duration | Total slack | Free slack | Constraint | Responsible | Text9 | Task Status | Update Version | Sched Status | MHHS Resource Name | RAG |
| --- | --- | --- | --- | --- | --- | --- | --- | --- | --- | --- | --- | --- | --- | --- | --- | --- | --- | --- | --- | --- | --- |
| 179 | 1.3.6.2 | **Design Handover** | 741d? | 2024-09-02 A | 2027-07-05 |  | 2% | 722.52d? | 2024-09-02 | 2027-07-05 | 0d | 123d |  |  | Design | DBT | -694.67 | 6.1 | Overdue Start | Paul Pettit | RED |
| 180 | 1.3.6.2.1 | **Creation of the Configuration Management Database** | 14d | 2024-09-02 | 2024-09-19 |  |  |  | 2024-09-02 | 2024-09-19 | 0d | 850d |  |  | Design | DBT | -701.67 | 6.1 | Overdue Start | Paul Pettit | RED |
| 181 | 1.3.6.2.1.1 | Identify all baselined design artefacts | 9d | 2024-09-02 | 2024-09-12 |  |  |  | 2024-09-02 | 2024-09-12 | 0d | 850d | 0d | start no earlier than 2024-09-02 | Design | DBT | -58.67 | 6.1 | Overdue Start | Paul Pettit | RED |
| 182 | 1.3.6.2.1.2 | Create CMBD | 5d | 2024-09-13 | 2024-09-19 | 181 |  |  | 2024-09-13 | 2024-09-19 | 0d | 850d |  |  | Design | DBT | -47.67 | 6.1 | Overdue Start | Paul Pettit | RED |
| 183 | 1.3.6.2.2 | **Knowledge Transfer** | 41d? | 2024-09-02 | 2024-10-28 |  |  |  | 2024-09-02 | 2024-10-28 | 0d | 823d |  |  | Design | DBT | -701.67 | 6.1 | Overdue Start | Paul Pettit | RED |
| 184 | 1.3.6.2.2.1 | Elexon to document knowledge transfer requirements | 9d? | 2024-09-02 | 2024-09-12 |  |  |  | 2024-09-02 | 2024-09-12 | 0d | 834d | 0d | start no earlier than 2024-09-02 | Design | DBT | -58.67 | 6.1 | Overdue Start | Paul Pettit | RED |
| 185 | 1.3.6.2.2.2 | Review Requirements | 5d | 2024-09-13 | 2024-09-19 | 184 |  |  | 2024-09-13 | 2024-09-19 | 0d | 834d | 0d |  | Design | DBT | -47.67 | 6.1 | Overdue Start | Paul Pettit | RED |
| 186 | 1.3.6.2.2.3 | Agree Success Criteria | 10d | 2024-09-20 | 2024-10-03 | 185 |  |  | 2024-09-20 | 2024-10-03 | 0d | 834d | 0d |  | Design | DBT | -40.67 | 6.1 | Overdue Start | Paul Pettit | RED |
| 187 | 1.3.6.2.2.4 | Identify Key personel with Elexon | 3d | 2024-10-04 | 2024-10-08 | 186 |  |  | 2024-10-04 | 2024-10-08 | 0d | 834d | 0d |  | Design | DBT | -26.67 | 6.1 | Overdue Start | Paul Pettit | RED |
| 188 | 1.3.6.2.2.5 | Draft Agenda for initial meeting | 1d? | 2024-10-09 | 2024-10-09 | 187 |  |  | 2024-10-09 | 2024-10-09 | 0d | 834d | 0d |  | Design | DBT | -21.67 | 6.1 | Overdue Start | Paul Pettit | RED |
| 189 | 1.3.6.2.2.6 | Define cadence for handover sessions | 2d | 2024-10-10 | 2024-10-11 | 188 |  |  | 2024-10-10 | 2024-10-11 | 0d | 834d |  |  | Design | DBT | -20.67 | 6.1 | Overdue Start | Paul Pettit | RED |
| 190 | 1.3.6.2.2.7 | Share Design Information | 20d | 2024-09-02 | 2024-09-27 |  |  |  | 2024-09-02 | 2024-09-27 | 0d | 844d |  | start no earlier than 2024-09-02 | Design | DBT | -58.67 | 6.1 | Overdue Start | Paul Pettit | RED |
| 191 | 1.3.6.2.2.8 | Conduct Initial Handover Session | 20d? | 2024-10-01 | 2024-10-28 |  |  |  | 2024-10-01 | 2024-10-28 | 0d | 823d |  | start no earlier than 2024-10-01 | Design | DBT | -29.67 | 6.1 | Overdue Start | Paul Pettit | RED |
| 192 | 1.3.6.2.3 | **Triage Sessions** | 131d? | 2024-10-01 | 2025-04-01 |  |  |  | 2024-10-01 | 2025-04-01 | 0d | 712d |  |  | Design | DBT | -701.67 | 6.1 | Overdue Start | Paul Pettit | RED |
| 193 | 1.3.6.2.3.1 | Design Triage Sessions | 131d? | 2024-10-01 | 2025-04-01 |  |  |  | 2024-10-01 | 2025-04-01 | 0d | 712d |  | start no earlier than 2024-10-01 | Design | DBT | -29.67 | 6.1 | Overdue Start | Paul Pettit | RED |
| 194 | 1.3.6.2.3.2 | Test Triage Sessions | 131d? | 2024-10-01 | 2025-04-01 |  |  |  | 2024-10-01 | 2025-04-01 | 0d | 712d |  | finish no earlier than 2025-04-01 | Design | DBT | -29.67 | 6.1 | Overdue Start | Paul Pettit | RED |
| 195 | 1.3.6.2.4 | **Knowledge Base** | 9d | 2024-09-02 A | 2024-09-12 A |  | 100% |  | 2024-09-02 | 2024-09-12 | 0d |  |  |  | Design | DBT | -701.67 | 6.1 | Overdue Start | Paul Pettit | COMPLETE |
| 196 | 1.3.6.2.4.1 | Document Knowledge base update process | 4d | 2024-09-02 A | 2024-09-05 A |  | 100% |  | 2024-09-02 | 2024-09-05 | 0d |  |  | start no earlier than 2024-09-02 | Design | DBT |  | 6.1 | Complete | Paul Pettit | COMPLETE |
| 197 | 1.3.6.2.4.2 | Document Design updates to Collaboration Base | 5d | 2024-09-06 A | 2024-09-12 A |  | 100% |  | 2024-09-06 | 2024-09-12 | 0d |  |  | start no earlier than 2024-09-06 | Design | DBT |  | 6.1 | Complete | Paul Pettit | COMPLETE |
| 198 | 1.3.6.2.5 | **FreshDesk** | 30d? | 2025-02-03 | 2025-03-14 |  |  |  | 2025-02-03 | 2025-03-14 | 0d | 724d |  |  | Design | DBT | -701.67 | 6.1 | Overdue Start | Paul Pettit | GREEN |
| 199 | 1.3.6.2.5.1 | Agree Indicative Handover of FreshDesk Calls to Service Now | 4d | 2025-02-03 | 2025-02-06 |  |  |  | 2025-02-03 | 2025-02-06 | 0d | 750d |  | start no earlier than 2025-02-03 | Design | DBT | 95.33 | 6.1 | Green | Paul Pettit | GREEN |
| 200 | 1.3.6.2.5.2 | Prepare Comms to Industry | 10d | 2025-02-07 | 2025-02-20 |  |  |  | 2025-02-07 | 2025-02-20 | 0d | 740d |  | start no earlier than 2025-02-07 | Design | DBT | 99.33 | 6.1 | Green | Paul Pettit | GREEN |
| 201 | 1.3.6.2.5.3 | Issue Comms to Industry | 1d? | 2025-02-21 | 2025-02-21 |  |  |  | 2025-02-21 | 2025-02-21 | 0d | 739d |  | start no earlier than 2025-02-21 | Design | DBT | 113.33 | 6.1 | Green | Paul Pettit | GREEN |
| 202 | 1.3.6.2.5.4 | Redirect Design Mailbox to Service Now | 1d? | 2025-03-03 | 2025-03-03 |  |  |  | 2025-03-03 | 2025-03-03 | 0d | 733d |  | start no earlier than 2025-03-03 | Design | DBT | 123.33 | 6.1 | Green | Paul Pettit | GREEN |
| 203 | 1.3.6.2.5.5 | Archive Freshdesk calls | 5d | 2025-03-03 | 2025-03-07 |  |  |  | 2025-03-03 | 2025-03-07 | 0d | 729d |  | start no earlier than 2025-03-03 | Design | DBT | 123.33 | 6.1 | Green | Paul Pettit | GREEN |
| 204 | 1.3.6.2.5.6 | Decommission FreshDesk | 5d | 2025-03-10 | 2025-03-14 |  |  |  | 2025-03-10 | 2025-03-14 | 0d | 724d |  | start no earlier than 2025-03-10 | Design | DBT | 130.33 | 6.1 | Green | Paul Pettit | GREEN |

| ID | WBS | Task | Type | Duration | Start | Finish | Predecessors | Complete | Remaining | Baseline start | Baseline finish | Baseline duration | Baseline 1 start | Baseline 1 finish | Total slack | Free slack | Constraint | Baseline cost | Responsible | Text9 | Task Status | Update Version | Sched Status | MHHS Resource Name | RAG | Involved | MHHS Programme Phase | Milestone ID | Text29 | Tier | Artefact ID |
| --- | --- | --- | --- | --- | --- | --- | --- | --- | --- | --- | --- | --- | --- | --- | --- | --- | --- | --- | --- | --- | --- | --- | --- | --- | --- | --- | --- | --- | --- | --- | --- |
| 205 | 1.3.6.2.6 | **iServer** |  | 611d? | 2025-03-03 A | 2027-07-05 |  | 5% | 580.45d? | 2025-03-03 | 2027-07-05 | 0d |  |  |  |  |  |  | Design | DBT | -701.67 | 6.1 | Overdue Start | Paul Pettit | GREEN |  |  |  |  |  |  |
| 206 | 1.3.6.2.6.1 | Gather Licensing information |  | 1d? | 2025-03-03 A | 2025-03-03 A |  | 100% |  | 2025-03-03 | 2025-03-03 | 0d |  |  |  |  | start no earlier than 2025-03-03 |  | Design | DBT |  | 6.1 | Complete | Paul Pettit | COMPLETE |  |  |  |  |  |  |
| 207 | 1.3.6.2.6.2 | Clear down old information |  | 5d | 2025-03-03 | 2025-03-07 |  |  |  | 2025-03-03 | 2025-03-07 | 0d |  |  | 715d | 0d |  |  | Design | DBT | 123.33 | 6.1 | Green | Paul Pettit | GREEN |  |  |  |  |  |  |
| 208 | 1.3.6.2.6.3 | Clear down accounts |  | 2d | 2025-03-10 | 2025-03-11 | 207 |  |  | 2025-03-10 | 2025-03-11 | 0d |  |  | 715d | 14d | start no earlier than 2025-03-10 |  | Design | DBT | 130.33 | 6.1 | Green | Paul Pettit | GREEN |  |  |  |  |  |  |
| 209 | 1.3.6.2.6.4 | Identify Collaboration Base Design Dependencies on iServer |  | 2d | 2025-04-01 | 2025-04-02 | 208 |  |  | 2025-04-01 | 2025-04-02 | 0d |  |  | 701d | 0d | start no earlier than 2025-04-01 |  | Design | DBT | 152.33 | 6.1 | Green | Paul Pettit | GREEN |  |  |  |  |  |  |
| 210 | 1.3.6.2.6.5 | Remove Design dependencies |  | 5d | 2025-04-03 | 2025-04-09 | 209 |  |  | 2025-04-03 | 2025-04-09 | 0d |  |  | 701d | 0d | start no earlier than 2025-04-03 |  | Design | DBT | 154.33 | 6.1 | Green | Paul Pettit | GREEN |  |  |  |  |  |  |
| 211 | 1.3.6.2.6.6 | Close down iServer |  | 5d | 2025-04-10 | 2025-04-16 | 210 |  |  | 2025-04-10 | 2025-04-16 | 0d |  |  | 701d |  | start no earlier than 2025-04-10 |  | Design | DBT | 161.33 | 6.1 | Green | Paul Pettit | GREEN |  |  |  |  |  |  |
| 212 | 1.3.6.3 | **Central Systems DBT** |  | 325d | 2022-10-31 A | 2024-01-26 A |  | 100% |  | 2022-10-31 | 2024-01-26 | 345d | 2022-10-31 | 2024-05-13 |  |  |  | -0 | N/A | DBT | -316.67 | 5.0 |  | N/A |  | N/A | Design, Build & Test (PIT) |  |  |  |  |
| 213 | 1.3.6.3.1 | **Elexon Central Systems DBT CIT (Entering at Interval 1)** |  | 248d | 2022-10-31 A | 2023-10-11 A |  | 100% |  | 2022-10-31 | 2023-10-11 | 249d | 2022-10-31 | 2023-09-29 |  |  |  | -0 | N/A | DBT |  | 5.0 |  | N/A |  | N/A | Design, Build & Test (PIT) |  |  |  |  |
| 214 | 1.3.6.3.1.1 | **Design and Build** |  | 235d | 2022-10-31 A | 2023-09-22 A |  | 100% |  | 2022-10-31 | 2023-09-22 | 240d | 2022-10-31 | 2023-09-29 |  |  |  |  | N/A | DBT | -259.67 | 5.0 |  | N/A |  | N/A | Design, Build & Test (PIT) |  |  |  |  |
| 215 | 1.3.6.3.1.1.1 | Helix Design and Build |  | 235d | 2022-10-31 A | 2023-09-22 A | 2 | 100% |  | 2022-10-31 | 2023-09-22 | 240d | 2022-10-31 | 2023-09-29 |  |  |  |  | PP | DBT |  | 5.0 | Complete |  | COMPLETE | SI Test | Design, Build & Test (PIT) |  |  |  |  |
| 216 | 1.3.6.3.1.2 | **Test Approach & Plan** |  | 235d | 2022-10-31 A | 2023-09-22 A |  | 100% |  | 2022-10-31 | 2023-09-22 | 235d | 2022-10-31 | 2023-07-21 |  |  |  | -0 | N/A | DBT |  | 5.0 |  | N/A |  | N/A | Design, Build & Test (PIT) |  |  |  |  |
| 217 | 1.3.6.3.1.2.1 | Develop Test Approach & Plan |  | 180d | 2022-10-31 A | 2023-07-07 A |  | 100% |  | 2022-10-31 | 2023-07-07 | 180d | 2022-10-31 | 2023-07-07 |  |  |  |  | PP | DBT |  | 5.0 | Complete |  | COMPLETE | SI Test | Design, Build & Test (PIT) |  |  |  |  |
| 218 | 1.3.6.3.1.2.2 | Elexon Central Systems Test Approach & Plan (PIT) submitted to Programme for assurance | milestone | 0d | 2023-07-13 A | 2023-07-13 A | 217FF+4d | 100% |  | 2023-07-13 | 2023-07-13 | 0d | 2023-07-07 | 2023-07-07 |  |  |  |  | PP | DBT |  | 5.0 | Complete |  | COMPLETE | SI Test | Design, Build & Test (PIT) | T3-DB-0029 | SITAG | T3 |  |
| 219 | 1.3.6.3.1.2.3 | Elexon Central Systems Test Approach & Plan (PIT) V2 resubmitted to Programme for assurance | milestone, manual | 0d | 2023-07-27 A | 2023-07-27 A | 218FS+9d | 100% |  | 2023-07-27 | 2023-07-27 | 0d |  |  |  |  |  |  | PP | DBT |  | 5.4 | Complete |  | COMPLETE | SI Test | Design, Build & Test (PIT) |  |  |  |  |
| 220 | 1.3.6.3.1.2.4 | Elexon Central Systems Test Approach & Plan (PIT) V3 resubmitted to Programme for assurance | milestone | 0d | 2023-08-18 A | 2023-08-18 A | 219FS+17d | 100% |  | 2023-08-18 | 2023-08-18 | 0d |  |  |  |  |  |  | PP | DBT |  | 5.4 | Complete |  | COMPLETE | SI Test | Design, Build & Test (PIT) |  |  |  |  |
| 221 | 1.3.6.3.1.2.5 | Elexon Central Systems Test approach and plan MHHS Review Completed | milestone | 0d | 2023-09-22 A | 2023-09-22 A | 220FS+25d | 100% |  | 2023-09-22 | 2023-09-22 | 0d | 2023-07-10 | 2023-07-21 |  |  |  |  | SI Test | DBT |  | 5.8 | Complete |  | COMPLETE | PP | Design, Build & Test (PIT) | T3-DB-0106 | SITAG | T3 |  |
| 222 | 1.3.6.3.1.3 | **Test Readiness Report** |  | 16d | 2023-07-28 A | 2023-08-18 A |  | 100% |  | 2023-07-28 | 2023-08-18 | 51d | 2023-07-21 | 2023-09-29 |  |  |  |  | N/A | DBT |  | 5.0 |  | N/A |  | N/A | Design, Build & Test (PIT) |  |  |  |  |
| 223 | 1.3.6.3.1.3.1 | Test readiness reporting |  | 16d | 2023-07-28 A | 2023-08-18 A | 218FS+10d | 100% |  | 2023-07-28 | 2023-08-18 | 51d | 2023-07-21 | 2023-09-29 |  |  |  |  | PP | DBT |  | 5.0 | Complete |  | COMPLETE | 109 | Design, Build & Test (PIT) |  |  |  |  |
| 224 | 1.3.6.3.1.4 | **Requirements to test Traceability Matrix (RTTM)** |  | 35d | 2023-08-04 A | 2023-09-22 A |  | 100% |  | 2023-08-04 | 2023-09-22 | 35d | 2022-10-31 | 2023-08-18 |  |  |  | -0 | N/A | DBT |  | 5.0 |  | N/A |  | N/A | Design, Build & Test (PIT) |  |  |  |  |
| 225 | 1.3.6.3.1.4.1 | Elexon Central Systems RTTM submitted to Programme for assurance | milestone | 0d | 2023-08-04 A | 2023-08-04 A | 218 | 100% |  | 2023-08-04 | 2023-08-04 | 0d | 2023-08-04 | 2023-08-04 |  |  | start no earlier than 2023-04-28 |  | PP | DBT |  | 5.0 | Complete |  | COMPLETE | SI Test | Design, Build & Test (PIT) | T3-DB-0030 | SITAG | T3 | MHHS-ART009 |
| 226 | 1.3.6.3.1.4.2 | Elexon Central Systems RTTM MHHS Review Completed | milestone | 0d | 2023-09-22 A | 2023-09-22 A | 225FS+35d | 100% |  | 2023-09-22 | 2023-09-22 | 0d | 2023-08-07 | 2023-08-18 |  |  |  |  | SI Test | DBT |  | 5.8 | Complete |  | COMPLETE | PP | Design, Build & Test (PIT) | T3-DB-0107 | SITAG | T3 |  |
| 227 | 1.3.6.3.1.5 | **Test Scenarios** |  | 35d | 2023-08-04 A | 2023-09-22 A |  | 100% |  | 2023-08-04 | 2023-09-22 | 35d | 2022-10-31 | 2023-08-18 |  |  |  | -0 | N/A | DBT |  | 5.0 |  | N/A |  | N/A | Design, Build & Test (PIT) |  |  |  |  |
| 228 | 1.3.6.3.1.5.1 | Elexon Central Systems test scenarios submitted to Programme for assurance | milestone | 0d | 2023-08-04 A | 2023-08-04 A | 218 | 100% |  | 2023-08-04 | 2023-08-04 | 0d | 2023-08-04 | 2023-08-04 |  |  |  |  | PP | DBT |  | 5.0 | Complete |  | COMPLETE | SI Test | Design, Build & Test (PIT) | T3-DB-0032 | SITAG | T3 |  |
| 229 | 1.3.6.3.1.5.2 | Elexon Central Systems Test scenarios MHHS Review Completed | milestone | 0d | 2023-09-22 A | 2023-09-22 A | 228FS+35d | 100% |  | 2023-09-22 | 2023-09-22 | 0d | 2023-08-07 | 2023-08-18 |  |  |  |  | SI Test | DBT |  | 5.8 | Complete |  | COMPLETE | PP | Design, Build & Test (PIT) | T3-DB-0108 | SITAG | T3 |  |

| ID | WBS | Task | Type | Duration | Start | Finish | Predecessors | Complete | Baseline start | Baseline finish | Baseline duration | Baseline 1 start | Baseline 1 finish | Constraint | Baseline cost | Responsible | Involved | Text9 | Update Version | MHHS Resource Name | MHHS Programme Phase | Sched Status | RAG | Milestone ID | Text29 | Tier | Artefact ID |
| --- | --- | --- | --- | --- | --- | --- | --- | --- | --- | --- | --- | --- | --- | --- | --- | --- | --- | --- | --- | --- | --- | --- | --- | --- | --- | --- | --- |
| 230 | 1.3.6.3.1.6 | **PIT Execution** |  | 38d | 2023-08-21 A | 2023-10-11 A |  | 100% | 2023-08-21 | 2023-10-11 | 248d | 2022-10-31 | 2023-09-29 |  | -0 | N/A | N/A | DBT | 5.0 | N/A | Design, Build & Test (PIT) |  |  |  |  |  |  |
| 231 | 1.3.6.3.1.6.1 | PIT Test Execution Progress Report |  | 18d | 2023-09-04 A | 2023-09-27 A | 223FS+10d | 100% | 2023-09-04 | 2023-09-27 | 235d | 2022-10-31 | 2023-09-22 |  |  | PP | SI Test | DBT | 5.1 |  | Design, Build & Test (PIT) | Complete | COMPLETE |  |  |  |  |
| 232 | 1.3.6.3.1.6.2 | Elexon Central Systems PIT Execution |  | 28d | 2023-08-21 A | 2023-09-27 A | 223 | 100% | 2023-08-21 | 2023-09-27 | 240d | 2022-10-31 | 2023-09-29 |  |  | PP | SI Test | DBT | 5.1 |  | Design, Build & Test (PIT) | Complete | COMPLETE |  |  |  |  |
| 233 | 1.3.6.3.1.6.3 | Elexon Central Systems PIT Completion Report submitted to Programme for assurance | milestone | 0d | 2023-09-27 A | 2023-09-27 A | 232 | 100% | 2023-09-27 | 2023-09-27 | 0d | 2024-01-05 | 2024-01-05 |  |  | PP | SI Test | DBT | 5.8 |  | Design, Build & Test (PIT) | Complete | COMPLETE | T3-DB-0109 | SITAG | T3 |  |
| 234 | 1.3.6.3.1.6.4 | Elexon Central Systems PIT Completion Report MHHS Review Completed | milestone | 0d | 2023-10-11 A | 2023-10-11 A | 226, 229, 231, 233FS+10d, 221 | 100% | 2023-10-11 | 2023-10-11 | 0d |  |  |  |  | SI Test | PP | DBT | 5.8 |  | Design, Build & Test (PIT) | Complete | COMPLETE | T3-DB-0110 | SITAG | T3 |  |
| 235 | 1.3.6.3.2 | **DIP DBT CIT (Entering at Interval 1)** |  | 221d | 2023-01-02 A | 2023-11-06 A |  | 100% | 2023-01-02 | 2023-11-06 | 266d | 2022-10-31 | 2023-09-29 |  | -0 | N/A | N/A | DBT | 5.0 | N/A | Design, Build & Test (PIT) |  |  |  |  |  |  |
| 236 | 1.3.6.3.2.1 | Design |  | 80d | 2023-01-02 A | 2023-04-21 A |  | 100% | 2023-01-02 | 2023-04-21 | 80d | 2023-01-02 | 2023-04-21 | must start on 2023-01-02 |  | PP | SI Design | DBT | 5.0 |  | Design, Build & Test (PIT) | Complete | COMPLETE |  |  |  |  |
| 237 | 1.3.6.3.2.2 | Build |  | 155d | 2023-01-09 A | 2023-08-11 A | 236SS+5d | 100% | 2023-01-09 | 2023-08-11 | 155d | 2023-01-09 | 2023-08-11 |  |  | PP |  | DBT | 5.5 |  | Design, Build & Test (PIT) | Complete | COMPLETE |  |  |  |  |
| 238 | 1.3.6.3.2.3 | **Test Approach & Plan** |  | 9d | 2023-07-07 A | 2023-07-20 A |  | 100% | 2023-07-07 | 2023-07-20 | 190d | 2022-10-31 | 2023-07-21 |  |  | N/A | N/A | DBT | 5.0 | N/A | Design, Build & Test (PIT) |  |  |  |  |  |  |
| 239 | 1.3.6.3.2.3.1 | DIP Test Approach & Plan (PIT) submitted to Programme for assurance | milestone | 0d | 2023-07-07 A | 2023-07-07 A |  | 100% | 2023-07-07 | 2023-07-07 | 0d | 2023-07-07 | 2023-07-07 |  |  | PP | SI Test | DBT | 5.0 |  | Design, Build & Test (PIT) | Complete | COMPLETE | T3-DB-0026 | SITAG | T3 | MHHS-ART073 |
| 240 | 1.3.6.3.2.3.2 | DIP Test Approach & Plan (PIT) MHHS Review Completed | milestone | 0d | 2023-07-20 A | 2023-07-20 A | 239FS+9d | 100% | 2023-07-20 | 2023-07-20 | 10d | 2023-07-10 | 2023-07-21 |  |  | SI Test | PP | DBT | 5.0 |  | Design, Build & Test (PIT) | Complete | COMPLETE |  |  |  |  |
| 241 | 1.3.6.3.2.4 | **PIT Test Readiness Report** |  | 31d | 2023-07-21 A | 2023-09-01 A |  | 100% | 2023-07-21 | 2023-09-01 | 51d | 2023-07-21 | 2023-09-29 |  |  | N/A | N/A | DBT | 5.0 | N/A | Design, Build & Test (PIT) |  |  |  |  |  |  |
| 242 | 1.3.6.3.2.4.1 | Test readiness reporting |  | 31d | 2023-07-21 A | 2023-09-01 A | 239FS+9d | 100% | 2023-07-21 | 2023-09-01 | 51d | 2023-07-21 | 2023-09-29 |  |  | SI Test | 109 | DBT | 5.0 |  | Design, Build & Test (PIT) | Complete | COMPLETE |  |  |  |  |
| 243 | 1.3.6.3.2.5 | **Requirements to test Traceability Matrix (RTTM)** |  | 18d | 2023-08-04 A | 2023-08-30 A |  | 100% | 2023-08-04 | 2023-08-30 | 210d | 2022-10-31 | 2023-08-18 |  |  | N/A | N/A | DBT | 5.0 | N/A | Design, Build & Test (PIT) |  |  |  |  |  |  |
| 244 | 1.3.6.3.2.5.1 | DIP RTTM submitted to Programme for assurance | milestone | 0d | 2023-08-04 A | 2023-08-04 A | 239FS+15d | 100% | 2023-08-04 | 2023-08-04 | 0d | 2023-08-04 | 2023-08-04 |  |  | PP | SI Test | DBT | 5.6 |  | Design, Build & Test (PIT) | Complete | COMPLETE | T3-DB-0034 | SITAG | T3 | MHHS-ART009 |
| 245 | 1.3.6.3.2.5.2 | DIP RTTM MHHS Review Completed | milestone | 0d | 2023-08-30 A | 2023-08-30 A | 244FS+18d | 100% | 2023-08-30 | 2023-08-30 | 10d | 2023-08-07 | 2023-08-18 |  |  | SI Test | PP | DBT | 5.0 |  | Design, Build & Test (PIT) | Complete | COMPLETE |  |  |  |  |
| 246 | 1.3.6.3.2.6 | **Test Scenarios** |  | 22d | 2023-07-31 A | 2023-08-30 A |  | 100% | 2023-07-31 | 2023-08-30 | 206d | 2022-10-31 | 2023-08-18 |  |  | N/A | N/A | DBT | 5.0 | N/A | Design, Build & Test (PIT) |  |  |  |  |  |  |
| 247 | 1.3.6.3.2.6.1 | DIP PIT test scenarios submitted to Programme for assurance | milestone | 0d | 2023-07-31 A | 2023-07-31 A | 239FS+15d | 100% | 2023-07-31 | 2023-07-31 | 0d | 2023-08-04 | 2023-08-04 |  |  | PP | SI Test | DBT | 5.0 |  | Design, Build & Test (PIT) | Complete | COMPLETE | T3-DB-0036 | SITAG | T3 |  |
| 248 | 1.3.6.3.2.6.2 | DIP Test scenarios MHHS Review Completed | milestone | 0d | 2023-08-30 A | 2023-08-30 A | 247FS+22d | 100% | 2023-08-30 | 2023-08-30 | 10d | 2023-08-07 | 2023-08-18 |  |  | SI Test | PP | DBT | 5.0 |  | Design, Build & Test (PIT) | Complete | COMPLETE |  |  |  |  |
| 249 | 1.3.6.3.2.7 | **PIT execution** |  | 50d | 2023-08-29 A | 2023-11-06 A |  | 100% | 2023-08-29 | 2023-11-06 | 47d | 2022-10-31 | 2023-09-29 |  | -0 | N/A | N/A | DBT | 5.0 | N/A | Design, Build & Test (PIT) |  |  |  |  |  |  |
| 250 | 1.3.6.3.2.7.1 | PIT Test Execution Progress Report |  | 37d | 2023-09-01 A | 2023-10-23 A | 251FF, 242 | 100% | 2023-09-01 | 2023-10-23 | 37d | 2022-10-31 | 2023-09-22 | start no earlier than 2023-08-29 |  | PP | SI Test | DBT | 5.6 |  | Design, Build & Test (PIT) | Complete | COMPLETE |  |  |  |  |
| 251 | 1.3.6.3.2.7.2 | PIT Execution (Interim Release 1) |  | 30d | 2023-08-29 A | 2023-10-09 A |  | 100% | 2023-08-29 | 2023-10-09 | 24d | 2022-10-31 | 2023-09-29 | start no earlier than 2023-08-29 |  | PP | SI Test | DBT | 5.6 |  | Design, Build & Test (PIT) | Complete | COMPLETE |  |  |  |  |
| 252 | 1.3.6.3.2.7.3 | PIT Execution (Interim Release 2) |  | 10d | 2023-10-10 A | 2023-10-23 A | 251 | 100% | 2023-10-10 | 2023-10-23 | 10d |  |  |  |  | PP | SI Test | DBT | 5.6 |  | Design, Build & Test (PIT) | Complete | COMPLETE |  |  |  |  |
| 253 | 1.3.6.3.2.7.4 | DIP PIT Completion Report (Interim Release 1) submitted to Programme for assurance | milestone | 0d | 2023-10-09 A | 2023-10-09 A | 251 | 100% | 2023-10-09 | 2023-10-09 | 0d | 2024-01-05 | 2024-01-05 |  |  | PP | SI Test | DBT | 5.8 |  | Design, Build & Test (PIT) | Complete | COMPLETE | T3-DB-0111 | SITAG | T3 |  |
| 254 | 1.3.6.3.2.7.5 | DIP PIT Completion Report (Interim Release 1) MHHS Review Completed | milestone | 0d | 2023-10-23 A | 2023-10-23 A | 253FS+10d | 100% | 2023-10-23 | 2023-10-23 | 0d |  |  |  |  | SI Test | SI Test | DBT | 5.10 |  | Design, Build & Test (PIT) | Complete | COMPLETE | T3-DB-0112 | SITAG | T3 |  |
| 255 | 1.3.6.3.2.7.6 | DIP PIT Completion Report (Interim Release 2) submitted to Programme for assurance | milestone | 0d | 2023-10-23 A | 2023-10-23 A | 252, 250 | 100% | 2023-10-23 | 2023-10-23 | 0d | 2024-01-05 | 2024-01-05 |  |  | PP | SI Test | DBT | 5.10 |  | Design, Build & Test (PIT) | Complete | COMPLETE | T3-DB-0113 | SITAG | T3 |  |
| 256 | 1.3.6.3.2.7.7 | DIP PIT Completion Report (Interim Release 2) MHHS Review Completed | milestone | 0d | 2023-11-06 A | 2023-11-06 A | 255FS+10d | 100% | 2023-11-06 | 2023-11-06 | 0d |  |  |  |  | SI Test | SI Test | DBT | 5.14 |  | Design, Build & Test (PIT) | Complete | COMPLETE | T3-DB-0114 | SITAG | T3 |  |

Notes:
- 242: Action: 14/8 - Query from RG - IS this an SI Test deliverable or expected to be a DIP deliverable if so be more specific
- 256: Guidance: 6/10 - LC - Successor should be SIT Component Integration Testing 1 Preparation Complete but not linked as DIP test completion plus 10 day review breaks logic. Decision will be made to proceed without a conclusion of the report review

| ID | WBS | Task | Type | Duration | Start | Finish | Predecessors | Complete | Baseline start | Baseline finish | Baseline duration | Baseline 1 start | Baseline 1 finish | Constraint | Baseline cost | Responsible | Involved | Text9 | Update Version | MHHS Resource Name | MHHS Programme Phase | Sched Status | RAG | Milestone ID | Text29 | Tier | Artefact ID |
| --- | --- | --- | --- | --- | --- | --- | --- | --- | --- | --- | --- | --- | --- | --- | --- | --- | --- | --- | --- | --- | --- | --- | --- | --- | --- | --- | --- |
| 257 | 1.3.6.3.3 | **DCC (DSP) DBT SIT Functional (Entering at SIT Functional)** |  | 325d | 2022-10-31 A | 2024-01-26 A |  | 100% | 2022-10-31 | 2024-01-26 | 345d | 2022-10-31 | 2024-01-05 |  | -0 | N/A | N/A | DBT | 5.18 | N/A | Design, Build & Test (PIT) |  |  |  |  |  |  |
| 258 | 1.3.6.3.3.1 | Design |  | 67d | 2022-10-31 A | 2023-01-31 A |  | 100% | 2022-10-31 | 2023-01-31 | 67d | 2022-10-31 | 2023-01-31 |  |  | PP | SI Design | DBT | 5.18 |  | Design, Build & Test (PIT) | Complete | COMPLETE |  |  |  |  |
| 259 | 1.3.6.3.3.2 | **Test Approach & Plan** |  | 20d | 2023-11-17 A | 2023-12-15 A |  | 100% | 2023-11-17 | 2023-12-15 | 20d | 2022-10-31 | 2023-10-27 |  | -0 | N/A | N/A | DBT | 5.18 | N/A | Design, Build & Test (PIT) |  |  |  |  |  |  |
| 260 | 1.3.6.3.3.2.1 | DCC Test Approach & Plan (PIT) submitted to Programme for assurance | milestone | 0d | 2023-11-17 A | 2023-11-17 A | 258FS+208d | 100% | 2023-11-17 | 2023-11-17 | 0d | 2023-10-13 | 2023-10-13 |  |  | PP | SI Test | DBT | 5.18 |  | Design, Build & Test (PIT) | Complete | COMPLETE | T3-DB-0068 | SITAG | T3 |  |
| 261 | 1.3.6.3.3.2.2 | DCC Test Approach & Plan (PIT) MHHS Review Completed | milestone | 0d | 2023-12-15 A | 2023-12-15 A | 260FS+20d | 100% | 2023-12-15 | 2023-12-15 | 0d | 2023-10-16 | 2023-10-27 |  |  | SI Test | PP | DBT | 5.18 |  | Design, Build & Test (PIT) | Complete | COMPLETE | T3-DB-0115 | SITAG | T3 |  |
| 262 | 1.3.6.3.3.3 | **Test Readiness Report** |  | 22d | 2023-12-04 A | 2024-01-02 A |  | 100% | 2023-12-04 | 2024-01-02 | 51d | 2023-10-27 | 2024-01-05 |  |  | N/A | N/A | DBT | 5.18 | N/A | Design, Build & Test (PIT) |  |  |  |  |  |  |
| 263 | 1.3.6.3.3.3.1 | Test readiness reporting |  | 22d | 2023-12-04 A | 2024-01-02 A | 260FS+10d | 100% | 2023-12-04 | 2024-01-02 | 51d | 2023-10-27 | 2024-01-05 |  |  | PP | 109 | DBT | 5.18 |  | Design, Build & Test (PIT) | Complete | COMPLETE |  |  |  |  |
| 264 | 1.3.6.3.3.4 | **Requirements to test Traceability Matrix (RTTM)** |  | 30d | 2023-12-15 A | 2024-01-26 A |  | 100% | 2023-12-15 | 2024-01-26 | 30d | 2022-10-31 | 2023-11-24 |  | -0 | N/A | N/A | DBT | 5.18 | N/A | Design, Build & Test (PIT) |  |  |  |  |  |  |
| 265 | 1.3.6.3.3.4.1 | DCC RTTM submitted to Programme for assurance | milestone | 0d | 2023-12-15 A | 2023-12-15 A | 260FS+20d | 100% | 2023-12-15 | 2023-12-15 | 0d | 2023-11-10 | 2023-11-10 | start no earlier than 2023-04-28 |  | PP | SI Test | DBT | 5.18 |  | Design, Build & Test (PIT) | Complete | COMPLETE | T3-DB-0074 | SITAG | T3 |  |
| 266 | 1.3.6.3.3.4.2 | DCC RTTM MHHS Review Completed | milestone | 0d | 2024-01-26 A | 2024-01-26 A | 265FS+30d | 100% | 2024-01-26 | 2024-01-26 | 0d | 2023-11-13 | 2023-11-24 |  |  | SI Test | PP | DBT | 5.18 |  | Design, Build & Test (PIT) | Complete | COMPLETE | T3-DB-0116 | SITAG | T3 |  |
| 267 | 1.3.6.3.3.5 | **Test Scenarios** |  | 30d | 2023-12-15 A | 2024-01-26 A |  | 100% | 2023-12-15 | 2024-01-26 | 30d | 2022-10-31 | 2023-11-24 |  | -0 | N/A | N/A | DBT | 5.18 | N/A | Design, Build & Test (PIT) |  |  |  |  |  |  |
| 268 | 1.3.6.3.3.5.1 | DCC test scenarios submitted to Programme for assurance | milestone | 0d | 2023-12-15 A | 2023-12-15 A | 260FS+20d | 100% | 2023-12-15 | 2023-12-15 | 0d | 2023-11-10 | 2023-11-10 |  |  | PP | SI Test | DBT | 5.18 |  | Design, Build & Test (PIT) | Complete | COMPLETE | T3-DB-0078 | SITAG | T3 |  |
| 269 | 1.3.6.3.3.5.2 | DCC Test Scenarios MHHS Review Completed | milestone | 0d | 2024-01-26 A | 2024-01-26 A | 268FS+30d | 100% | 2024-01-26 | 2024-01-26 | 0d | 2023-11-13 | 2023-11-24 |  |  | SI Test | PP | DBT | 5.18 |  | Design, Build & Test (PIT) | Complete | COMPLETE | T3-DB-0117 | SITAG | T3 |  |
| 270 | 1.3.6.3.4 | **RECCo (EES) DBT CIT (Entering at Interval 6)** |  | 71d | 2023-10-13 A | 2024-01-19 A |  | 100% | 2023-10-13 | 2024-01-19 | 320d | 2022-10-31 | 2024-01-05 |  | -0 | N/A | N/A | DBT | 5.0 | N/A | Design, Build & Test (PIT) |  |  |  |  |  |  |
| 271 | 1.3.6.3.4.1 | **Test Approach & Plan** |  | 20d | 2023-10-13 A | 2023-11-09 A |  | 100% | 2023-10-13 | 2023-11-09 | 20d | 2022-10-31 | 2023-10-27 |  | -0 | N/A | N/A | DBT | 5.0 | N/A | Design, Build & Test (PIT) |  |  |  |  |  |  |
| 272 | 1.3.6.3.4.1.1 | EES Test Approach & Plan (PIT) submitted to Programme for assurance | milestone | 0d | 2023-10-13 A | 2023-10-13 A |  | 100% | 2023-10-13 | 2023-10-13 | 0d | 2023-10-13 | 2023-10-13 | start no earlier than 2023-10-13 |  | PP | SI Test | DBT | 5.8 |  | Design, Build & Test (PIT) | Complete | COMPLETE | T3-DB-0066 | SITAG | T3 |  |
| 273 | 1.3.6.3.4.1.2 | EES Test approach and plan (PIT) MHHS Review Completed | milestone | 0d | 2023-11-09 A | 2023-11-09 A | 272FS+20d | 100% | 2023-11-09 | 2023-11-09 | 0d | 2023-10-16 | 2023-10-27 |  |  | SI Test | PP | DBT | 5.8 |  | Design, Build & Test (PIT) | Complete | COMPLETE | T3-DB-0119 | SITAG | T3 |  |
| 274 | 1.3.6.3.4.2 | **Test Readiness Report** |  | 10d | 2023-10-27 A | 2023-11-09 A |  | 100% | 2023-10-27 | 2023-11-09 | 51d | 2023-10-27 | 2024-01-05 |  |  | N/A | N/A | DBT | 5.0 | N/A | Design, Build & Test (PIT) |  |  |  |  |  |  |
| 275 | 1.3.6.3.4.2.1 | Test readiness reporting |  | 10d | 2023-10-27 A | 2023-11-09 A | 272FS+10d | 100% | 2023-10-27 | 2023-11-09 | 51d | 2023-10-27 | 2024-01-05 |  |  | PP | 109 | DBT | 5.0 |  | Design, Build & Test (PIT) | Complete | COMPLETE |  |  |  |  |
| 276 | 1.3.6.3.4.3 | **Requirements to test Traceability Matrix (RTTM)** |  | 20d | 2023-11-02 A | 2023-11-30 A |  | 100% | 2023-11-02 | 2023-11-30 | 20d | 2022-10-31 | 2023-11-24 |  | -0 | N/A | N/A | DBT | 5.0 | N/A | Design, Build & Test (PIT) |  |  |  |  |  |  |
| 277 | 1.3.6.3.4.3.1 | EES RTTM submitted to Programme for assurance | milestone | 0d | 2023-11-02 A | 2023-11-02 A | 272FS+15d | 100% | 2023-11-02 | 2023-11-02 | 0d | 2023-11-10 | 2023-11-10 |  |  | PP | SI Test | DBT | 5.8 |  | Design, Build & Test (PIT) | Complete | COMPLETE | T3-DB-0072 | SITAG | T3 | MHHS-ART009 |
| 278 | 1.3.6.3.4.3.2 | EES RTTM MHHS Review Completed | milestone | 0d | 2023-11-30 A | 2023-11-30 A | 277FS+20d | 100% | 2023-11-30 | 2023-11-30 | 0d | 2023-11-13 | 2023-11-24 |  |  | SI Test | PP | DBT | 5.14 |  | Design, Build & Test (PIT) | Complete | COMPLETE | T3-DB-0120 | SITAG | T3 |  |
| 279 | 1.3.6.3.4.4 | **Test Scenarios** |  | 20d | 2023-11-02 A | 2023-11-30 A |  | 100% | 2023-11-02 | 2023-11-30 | 20d | 2022-10-31 | 2023-11-24 |  | -0 | N/A | N/A | DBT | 5.0 | N/A | Design, Build & Test (PIT) |  |  |  |  |  |  |
| 280 | 1.3.6.3.4.4.1 | EES test scenarios submitted to Programme for assurance | milestone | 0d | 2023-11-02 A | 2023-11-02 A | 272FS+15d | 100% | 2023-11-02 | 2023-11-02 | 0d | 2023-11-10 | 2023-11-10 |  |  | PP | SI Test | DBT | 5.8 |  | Design, Build & Test (PIT) | Complete | COMPLETE | T3-DB-0031 | SITAG | T3 |  |
| 281 | 1.3.6.3.4.4.2 | EES Test scenarios MHHS Review Completed | milestone | 0d | 2023-11-30 A | 2023-11-30 A | 280FS+20d | 100% | 2023-11-30 | 2023-11-30 | 0d | 2023-11-13 | 2023-11-24 |  |  | SI Test | PP | DBT | 5.14 |  | Design, Build & Test (PIT) | Complete | COMPLETE | T3-DB-0121 | SITAG | T3 |  |

| ID | WBS | Task | Type | Duration | Start | Finish | Predecessors | Complete | Remaining | Baseline start | Baseline finish | Baseline duration | Baseline 1 start | Baseline 1 finish | Total slack | Constraint | Baseline cost | Responsible | Involved | Text9 | Update Version | MHHS Resource Name | MHHS Programme Phase | Sched Status | RAG | Milestone ID | Text29 | Tier | Artefact ID |
| --- | --- | --- | --- | --- | --- | --- | --- | --- | --- | --- | --- | --- | --- | --- | --- | --- | --- | --- | --- | --- | --- | --- | --- | --- | --- | --- | --- | --- | --- |
| 282 | 1.3.6.3.4.5 | **PIT execution** |  | 51d | 2023-11-10 A | 2024-01-19 A |  | 100% |  | 2023-11-10 | 2024-01-19 | 320d | 2022-10-31 | 2024-01-05 |  |  | -0 | N/A | N/A | DBT | 5.0 | N/A | Design, Build & Test (PIT) |  |  |  |  |  |  |
| 283 | 1.3.6.3.4.5.1 | PIT Test Execution Progress Report |  | 41d | 2023-11-10 A | 2024-01-05 A | 275 | 100% |  | 2023-11-10 | 2024-01-05 | 41d | 2022-10-31 | 2023-12-29 |  |  |  | PP | SI Test | DBT | 5.0 |  | Design, Build & Test (PIT) | Complete | COMPLETE |  |  |  |  |
| 284 | 1.3.6.3.4.5.2 | PIT Execution |  | 41d | 2023-11-10 A | 2024-01-05 A | 280FS+5d | 100% |  | 2023-11-10 | 2024-01-05 | 310d | 2022-10-31 | 2024-01-05 |  |  |  | PP | SI Test | DBT | 5.0 |  | Design, Build & Test (PIT) | Complete | COMPLETE |  |  |  |  |
| 285 | 1.3.6.3.4.5.3 | EES PIT Completion Report submitted to Programme for assurance | milestone | 0d | 2024-01-05 A | 2024-01-05 A | 283, 284 | 100% |  | 2024-01-05 | 2024-01-05 | 0d | 2024-01-05 | 2024-01-05 |  |  |  | PP | SI Test | DBT | 5.14 |  | Design, Build & Test (PIT) | Complete | COMPLETE | T3-DB-0122 | SITAG | T3 |  |
| 286 | 1.3.6.3.4.5.4 | EES PIT Completion Report MHHS Review Completed | milestone | 0d | 2024-01-19 A | 2024-01-19 A | 273, 278, 281, 285FS+10d | 100% |  | 2024-01-19 | 2024-01-19 | 0d |  |  |  |  |  | SI Test | PP | DBT | 5.14 |  | Design, Build & Test (PIT) | Complete | COMPLETE | T3-DB-0123 | SITAG | T3 |  |
| 287 | 1.3.6.3.5 | **Registration Services DBT CIT (Entering at Interval 2)** |  | 70d | 2023-07-28 A | 2023-11-03 A |  | 100% |  | 2023-07-28 | 2023-11-03 | 70d | 2022-10-31 | 2024-02-28 |  |  | -0 | N/A | N/A | DBT | 5.0 | N/A | Design, Build & Test (PIT) |  |  |  |  |  |  |
| 288 | 1.3.6.3.5.1 | **Test Approach & Plan** |  | 40d | 2023-07-28 A | 2023-09-22 A |  | 100% |  | 2023-07-28 | 2023-09-22 | 40d | 2022-10-31 | 2023-08-11 |  |  | -0 | N/A | N/A | DBT | 5.0 | N/A | Design, Build & Test (PIT) |  |  |  |  |  |  |
| 289 | 1.3.6.3.5.1.1 | Registration Services Test Approach & Plan (PIT) submitted to Programme for assurance | milestone | 0d | 2023-07-28 A | 2023-07-28 A |  | 100% |  | 2023-07-28 | 2023-07-28 | 0d | 2023-07-28 | 2023-07-28 |  |  |  | PP | SI Test | DBT | 5.0 |  | Design, Build & Test (PIT) | Complete | COMPLETE | T3-DB-0028 | SITAG | T3 | MHHS-ART073 |
| 290 | 1.3.6.3.5.1.2 | Registration Services Test approach and plan MHHS Review Completed | milestone | 0d | 2023-09-22 A | 2023-09-22 A | 289FS+40d | 100% |  | 2023-09-22 | 2023-09-22 | 0d | 2023-07-31 | 2023-08-11 |  |  |  | SI Test | PP | DBT | 5.8 |  | Design, Build & Test (PIT) | Complete | COMPLETE | T3-DB-0124 | SITAG | T3 |  |
| 291 | 1.3.6.3.5.2 | **Test Readiness Report** |  | 20d | 2023-08-14 A | 2023-09-08 A |  | 100% |  | 2023-08-14 | 2023-09-08 | 51d | 2023-08-11 | 2023-10-20 |  |  |  | N/A | N/A | DBT | 5.0 | N/A | Design, Build & Test (PIT) |  |  |  |  |  |  |
| 292 | 1.3.6.3.5.2.1 | Test readiness reporting |  | 20d | 2023-08-14 A | 2023-09-08 A | 289FS+10d | 100% |  | 2023-08-14 | 2023-09-08 | 51d | 2023-08-11 | 2023-10-20 |  |  |  | PP | 109 | DBT | 5.0 |  | Design, Build & Test (PIT) | Complete | COMPLETE |  |  |  |  |
| 293 | 1.3.6.3.5.3 | **Requirements to test Traceability Matrix (RTTM)** |  | 20d | 2023-09-01 A | 2023-09-29 A |  | 100% |  | 2023-09-01 | 2023-09-29 | 20d | 2022-10-31 | 2023-09-15 |  |  | -0 | N/A | N/A | DBT | 5.0 | N/A | Design, Build & Test (PIT) |  |  |  |  |  |  |
| 294 | 1.3.6.3.5.3.1 | Registration Services RTTM submitted to Programme for assurance | milestone | 0d | 2023-09-01 A | 2023-09-01 A | 289FS+15d | 100% |  | 2023-09-01 | 2023-09-01 | 0d | 2023-09-01 | 2023-09-01 |  | start no earlier than 2023-04-28 |  | PP | SI Test | DBT | 5.6 |  | Design, Build & Test (PIT) | Complete | COMPLETE | T3-DB-0042 | SITAG | T3 | MHHS-ART009 |
| 295 | 1.3.6.3.5.3.2 | Registration Services RTTM MHHS Review Completed | milestone | 0d | 2023-09-29 A | 2023-09-29 A | 294FS+20d | 100% |  | 2023-09-29 | 2023-09-29 | 0d | 2023-09-04 | 2023-09-15 |  |  |  | SI Test | PP | DBT | 5.8 |  | Design, Build & Test (PIT) | Complete | COMPLETE | T3-DB-0125 | SITAG | T3 |  |
| 296 | 1.3.6.3.5.4 | **Test Scenarios** |  | 20d | 2023-09-01 A | 2023-09-29 A |  | 100% |  | 2023-09-01 | 2023-09-29 | 20d | 2022-10-31 | 2023-09-15 |  |  | -0 | N/A | N/A | DBT | 5.0 | N/A | Design, Build & Test (PIT) |  |  |  |  |  |  |
| 297 | 1.3.6.3.5.4.1 | Registration Services test scenarios submitted to Programme for assurance | milestone | 0d | 2023-09-01 A | 2023-09-01 A | 289FS+15d | 100% |  | 2023-09-01 | 2023-09-01 | 0d | 2023-09-01 | 2023-09-01 |  |  |  | PP | SI Test | DBT | 5.6 |  | Design, Build & Test (PIT) | Complete | COMPLETE | T3-DB-0044 | SITAG | T3 |  |
| 298 | 1.3.6.3.5.4.2 | Registration Services Test scenarios MHHS Review Completed | milestone | 0d | 2023-09-29 A | 2023-09-29 A | 297FS+20d | 100% |  | 2023-09-29 | 2023-09-29 | 0d | 2023-09-04 | 2023-09-15 |  |  |  | SI Test | PP | DBT | 5.8 |  | Design, Build & Test (PIT) | Complete | COMPLETE | T3-DB-0126 | SITAG | T3 |  |
| 299 | 1.3.6.3.5.5 | **PIT execution** |  | 40d | 2023-09-11 A | 2023-11-03 A |  | 100% |  | 2023-09-11 | 2023-11-03 | 40d | 2023-01-02 | 2023-10-20 |  |  | -0 | N/A | N/A | DBT | 5.0 | N/A | Design, Build & Test (PIT) |  |  |  |  |  |  |
| 300 | 1.3.6.3.5.5.1 | PIT Test Execution Progress Report |  | 33d | 2023-09-11 A | 2023-10-25 A | 292 | 100% |  | 2023-09-11 | 2023-10-25 | 30d | 2023-01-02 | 2023-10-13 |  |  |  | PP | SI Test | DBT | 5.0 |  | Design, Build & Test (PIT) | Complete | COMPLETE |  |  |  |  |
| 301 | 1.3.6.3.5.5.2 | PIT Execution |  | 30d | 2023-09-11 A | 2023-10-20 A | 297FS+5d | 100% |  | 2023-09-11 | 2023-10-20 | 30d | 2023-01-16 | 2023-10-20 |  |  |  | PP | SI Test | DBT | 5.0 |  | Design, Build & Test (PIT) | Complete | COMPLETE |  |  |  |  |
| 302 | 1.3.6.3.5.5.3 | Registration Services PIT (CIT interval 2) Completion Report submitted to Programme for assurance | milestone | 0d | 2023-10-25 A | 2023-10-25 A | 300, 301 | 100% |  | 2023-10-25 | 2023-10-25 | 0d | 2024-01-05 | 2024-01-05 |  |  |  | PP | SI Test | DBT | 5.10 |  | Design, Build & Test (PIT) | Complete | COMPLETE | T3-DB-0127 | SITAG | T3 |  |
| 303 | 1.3.6.3.5.5.4 | Registration Services PIT (CIT interval 2) Completion Report MHHS Review Completed | milestone | 0d | 2023-11-03 A | 2023-11-03 A | 290, 295, 298, 302FS+7d | 100% |  | 2023-11-03 | 2023-11-03 | 0d |  |  |  |  |  | SI Test | PP | DBT | 5.11 |  | Design, Build & Test (PIT) | Complete | COMPLETE | T3-DB-0128 | SITAG | T3 |  |
| 304 | 1.3.6.4 | **SIT Participants DBT** |  | 356d | 2023-08-11 A | 2024-12-20 |  | 89% | 38.53d | 2023-08-11 | 2024-12-20 | 495d | 2022-10-31 | 2025-03-14 | 125d |  | -0 | N/A | N/A | DBT | 5.0 | N/A | Design, Build & Test (PIT) |  |  |  |  |  |  |
| 305 | 1.3.6.4.1 | **All Data Services DBT CIT (Entering at Interval 3)** |  | 71d | 2023-08-11 A | 2023-11-17 A |  | 100% |  | 2023-08-11 | 2023-11-17 | 275d | 2022-10-31 | 2023-11-03 |  |  | -0 | N/A | N/A | DBT | 5.0 | N/A | Design, Build & Test (PIT) |  |  |  |  |  |  |
| 306 | 1.3.6.4.1.1 | **Test Approach & Plan** |  | 30d | 2023-08-11 A | 2023-09-21 A |  | 100% |  | 2023-08-11 | 2023-09-21 | 29d | 2022-10-31 | 2023-08-25 |  |  | -0 | N/A | N/A | DBT | 5.0 | N/A | Design, Build & Test (PIT) |  |  |  |  |  |  |
| 307 | 1.3.6.4.1.1.1 | All Data Services Test Approach & Plans (PIT) submitted to Programme for assurance | milestone | 0d | 2023-08-11 A | 2023-08-11 A |  | 100% |  | 2023-08-11 | 2023-08-11 | 0d | 2023-08-11 | 2023-08-11 |  | start no earlier than 2023-08-11 |  | PP | SI Test | DBT | 5.0 |  | Design, Build & Test (PIT) | Complete | COMPLETE | T3-DB-0038 | SITAG | T3 |  |
| 308 | 1.3.6.4.1.1.2 | All Data Services Test approach and plans MHHS Review Completed | milestone | 0d | 2023-09-21 A | 2023-09-21 A | 307FS+30d | 100% |  | 2023-09-21 | 2023-09-21 | 0d | 2023-08-14 | 2023-08-25 |  |  |  | SI Test | PP | DBT | 5.11 |  | Design, Build & Test (PIT) | Complete | COMPLETE | T3-DB-0129 | SITAG | T3 |  |

| ID | WBS | Task | Type | Duration | Start | Finish | Predecessors | Complete | Baseline start | Baseline finish | Baseline duration | Baseline 1 start | Baseline 1 finish | Baseline cost | Responsible | Involved | Text9 | Update Version | MHHS Resource Name | MHHS Programme Phase | Sched Status | RAG | Milestone ID | Text29 | Tier | Artefact ID |
| --- | --- | --- | --- | --- | --- | --- | --- | --- | --- | --- | --- | --- | --- | --- | --- | --- | --- | --- | --- | --- | --- | --- | --- | --- | --- | --- |
| 309 | 1.3.6.4.1.2 | **Test Readiness Report** |  | 11d | 2023-08-25 A | 2023-09-08 A |  | 100% | 2023-08-25 | 2023-09-08 | 11d | 2023-08-25 | 2023-11-03 | -0 | N/A | N/A | DBT | 5.0 | N/A | Design, Build & Test (PIT) |  |  |  |  |  |  |
| 310 | 1.3.6.4.1.2.1 | Test readiness reporting |  | 11d | 2023-08-25 A | 2023-09-08 A | 307FS+10d | 100% | 2023-08-25 | 2023-09-08 | 11d | 2023-08-25 | 2023-11-03 |  | PP | 109 | DBT | 5.0 |  | Design, Build & Test (PIT) | Complete | COMPLETE |  |  |  |  |
| 311 | 1.3.6.4.1.3 | **Requirements to test Traceability Matrix (RTTM)** |  | 7d | 2023-09-20 A | 2023-09-29 A |  | 100% | 2023-09-20 | 2023-09-29 | 5d | 2022-10-31 | 2023-10-06 | -0 | N/A | N/A | DBT | 5.0 | N/A | Design, Build & Test (PIT) |  |  |  |  |  |  |
| 312 | 1.3.6.4.1.3.1 | All Data Services RTTMs submitted to Programme for assurance | milestone | 0d | 2023-09-20 A | 2023-09-20 A | 307FS+29d | 100% | 2023-09-20 | 2023-09-20 | 0d | 2023-09-22 | 2023-09-22 |  | PP | SI Test | DBT | 5.7 |  | Design, Build & Test (PIT) | Complete | COMPLETE | T3-DB-0058 | SITAG | T3 |  |
| 313 | 1.3.6.4.1.3.2 | All Data Services RTTMs MHHS Review Completed | milestone | 0d | 2023-09-29 A | 2023-09-29 A | 312FS+7d | 100% | 2023-09-29 | 2023-09-29 | 0d | 2023-09-25 | 2023-10-06 |  | SI Test | PP | DBT | 5.8 |  | Design, Build & Test (PIT) | Complete | COMPLETE | T3-DB-0130 | SITAG | T3 |  |
| 314 | 1.3.6.4.1.4 | **Test Scenarios** |  | 6d | 2023-09-20 A | 2023-09-28 A |  | 100% | 2023-09-20 | 2023-09-28 | 4d | 2022-10-31 | 2023-10-06 | -0 | N/A | N/A | DBT | 5.0 | N/A | Design, Build & Test (PIT) |  |  |  |  |  |  |
| 315 | 1.3.6.4.1.4.1 | All Data Services test scenarios' submitted to Programme for assurance | milestone | 0d | 2023-09-20 A | 2023-09-20 A | 307FS+29d | 100% | 2023-09-20 | 2023-09-20 | 0d | 2023-09-22 | 2023-09-22 |  | PP | SI Test | DBT | 5.7 |  | Design, Build & Test (PIT) | Complete | COMPLETE | T3-DB-0056 | SITAG | T3 |  |
| 316 | 1.3.6.4.1.4.2 | All Data Services Test scenarios' MHHS Review Completed | milestone | 0d | 2023-09-28 A | 2023-09-28 A | 315FS+6d | 100% | 2023-09-28 | 2023-09-28 | 0d | 2023-09-25 | 2023-10-06 |  | SI Test | PP | DBT | 5.11 |  | Design, Build & Test (PIT) | Complete | COMPLETE | T3-DB-0131 | SITAG | T3 |  |
| 317 | 1.3.6.4.1.5 | **PIT execution** |  | 50d | 2023-09-11 A | 2023-11-17 A |  | 100% | 2023-09-11 | 2023-11-17 | 275d | 2022-10-31 | 2023-11-03 | -0 | N/A | N/A | DBT | 5.0 | N/A | Design, Build & Test (PIT) |  |  |  |  |  |  |
| 318 | 1.3.6.4.1.5.1 | PIT Test Execution Progress Report |  | 40d | 2023-09-11 A | 2023-11-03 A | 310 | 100% | 2023-09-11 | 2023-11-03 | 260d | 2022-10-31 | 2023-10-27 |  | PP | SI Test | DBT | 5.0 |  | Design, Build & Test (PIT) | Complete | COMPLETE |  |  |  |  |
| 319 | 1.3.6.4.1.5.2 | PIT Execution |  | 27d | 2023-09-28 A | 2023-11-03 A | 315FS+5d | 100% | 2023-09-28 | 2023-11-03 | 265d | 2022-10-31 | 2023-11-03 |  | PP | SI Test | DBT | 5.0 |  | Design, Build & Test (PIT) | Complete | COMPLETE |  |  |  |  |
| 320 | 1.3.6.4.1.5.3 | All Data Services PIT Completion Reports submitted to Programme for assurance | milestone | 0d | 2023-11-03 A | 2023-11-03 A | 318, 319 | 100% | 2023-11-03 | 2023-11-03 | 0d | 2024-01-05 | 2024-01-05 |  | PP | SI Test | DBT | 5.11 |  | Design, Build & Test (PIT) | Complete | COMPLETE | T3-DB-0132 | SITAG | T3 |  |
| 321 | 1.3.6.4.1.5.4 | All Data Services PIT Completion Reports MHHS Review Completed | milestone | 0d | 2023-11-17 A | 2023-11-17 A | 308, 313, 316, 320FS+10d | 100% | 2023-11-17 | 2023-11-17 | 0d |  |  |  | SI Test | PP | DBT | 5.13 |  | Design, Build & Test (PIT) | Complete | COMPLETE | T3-DB-0133 | SITAG | T3 |  |
| 322 | 1.3.6.4.2 | **All Metering Services DBT CIT (Entering at Interval 4)** |  | 70d | 2023-08-25 A | 2023-12-01 A |  | 100% | 2023-08-25 | 2023-12-01 | 285d | 2022-10-31 | 2023-11-17 | -0 | N/A | N/A | DBT | 5.0 | N/A | Design, Build & Test (PIT) |  |  |  |  |  |  |
| 323 | 1.3.6.4.2.1 | **Test Approach & Plan** |  | 40d | 2023-08-25 A | 2023-10-20 A |  | 100% | 2023-08-25 | 2023-10-20 | 40d | 2022-10-31 | 2023-09-08 | -0 | N/A | N/A | DBT | 5.0 | N/A | Design, Build & Test (PIT) |  |  |  |  |  |  |
| 324 | 1.3.6.4.2.1.1 | All Metering Services Test Approach & Plans (PIT) submitted to Programme for assurance | milestone | 0d | 2023-08-25 A | 2023-08-25 A |  | 100% | 2023-08-25 | 2023-08-25 | 0d | 2023-08-25 | 2023-08-25 |  | PP | SI Test | DBT | 5.6 |  | Design, Build & Test (PIT) | Complete | COMPLETE | T3-DB-0040 | SITAG | T3 |  |
| 325 | 1.3.6.4.2.1.2 | All Metering Services Test approach and plans MHHS Review Completed | milestone | 0d | 2023-10-20 A | 2023-10-20 A | 324FS+40d | 100% | 2023-10-20 | 2023-10-20 | 0d | 2023-08-28 | 2023-09-08 |  | SI Test | PP | DBT | 5.8 |  | Design, Build & Test (PIT) | Complete | COMPLETE | T3-DB-0134 | SITAG | T3 |  |
| 326 | 1.3.6.4.2.2 | **Test Readiness Report** |  | 11d | 2023-09-11 A | 2023-09-25 A |  | 100% | 2023-09-11 | 2023-09-25 | 51d | 2023-09-08 | 2023-11-17 |  | N/A | N/A | DBT | 5.0 | N/A | Design, Build & Test (PIT) |  |  |  |  |  |  |
| 327 | 1.3.6.4.2.2.1 | Test readiness reporting |  | 11d | 2023-09-11 A | 2023-09-25 A | 324FS+10d | 100% | 2023-09-11 | 2023-09-25 | 51d | 2023-09-08 | 2023-11-17 |  | PP | 109 | DBT | 5.0 |  | Design, Build & Test (PIT) | Complete | COMPLETE |  |  |  |  |
| 328 | 1.3.6.4.2.3 | **Requirements to test Traceability Matrix (RTTM)** |  | 30d | 2023-09-15 A | 2023-10-27 A |  | 100% | 2023-09-15 | 2023-10-27 | 30d | 2022-10-31 | 2023-09-29 | -0 | N/A | N/A | DBT | 5.0 | N/A | Design, Build & Test (PIT) |  |  |  |  |  |  |
| 329 | 1.3.6.4.2.3.1 | All Metering Services RTTMs submitted to Programme for assurance | milestone | 0d | 2023-09-15 A | 2023-09-15 A | 324FS+15d | 100% | 2023-09-15 | 2023-09-15 | 0d | 2023-09-15 | 2023-09-15 |  | PP | SI Test | DBT | 5.8 |  | Design, Build & Test (PIT) | Complete | COMPLETE | T3-DB-0048 | SITAG | T3 | MHHS-ART009 |
| 330 | 1.3.6.4.2.3.2 | All Metering Services MHHS Reviews Completed | milestone | 0d | 2023-10-27 A | 2023-10-27 A | 329FS+30d | 100% | 2023-10-27 | 2023-10-27 | 0d | 2023-09-18 | 2023-09-29 |  | SI Test | PP | DBT | 5.13 |  | Design, Build & Test (PIT) | Complete | COMPLETE | T3-DB-0135 | SITAG | T3 |  |
| 331 | 1.3.6.4.2.4 | **Test Scenarios** |  | 30d | 2023-09-15 A | 2023-10-27 A |  | 100% | 2023-09-15 | 2023-10-27 | 30d | 2022-10-31 | 2023-09-29 | -0 | N/A | N/A | DBT | 5.0 | N/A | Design, Build & Test (PIT) |  |  |  |  |  |  |
| 332 | 1.3.6.4.2.4.1 | All Metering Services test scenarios' submitted to Programme for assurance | milestone | 0d | 2023-09-15 A | 2023-09-15 A | 324FS+15d | 100% | 2023-09-15 | 2023-09-15 | 0d | 2023-09-15 | 2023-09-15 |  | PP | SI Test | DBT | 5.8 |  | Design, Build & Test (PIT) | Complete | COMPLETE | T3-DB-0050 | SITAG | T3 |  |
| 333 | 1.3.6.4.2.4.2 | All Metering Services Test scenarios' MHHS Review Completed | milestone | 0d | 2023-10-27 A | 2023-10-27 A | 332FS+30d | 100% | 2023-10-27 | 2023-10-27 | 0d | 2023-09-18 | 2023-09-29 |  | SI Test | PP | DBT | 5.13 |  | Design, Build & Test (PIT) | Complete | COMPLETE | T3-DB-0136 | SITAG | T3 |  |

| ID | WBS | Task | Type | Duration | Start | Finish | Predecessors | Complete | Remaining | Baseline start | Baseline finish | Baseline duration | Baseline 1 start | Baseline 1 finish | Total slack | Constraint | Baseline cost | Responsible | Involved | Text9 | Update Version | MHHS Resource Name | MHHS Programme Phase | Sched Status | RAG | Milestone ID | Text29 | Tier |
| --- | --- | --- | --- | --- | --- | --- | --- | --- | --- | --- | --- | --- | --- | --- | --- | --- | --- | --- | --- | --- | --- | --- | --- | --- | --- | --- | --- | --- |
| 334 | 1.3.6.4.2.5 | **PIT execution** |  | 50d | 2023-09-25 A | 2023-12-01 A |  | 100% |  | 2023-09-25 | 2023-12-01 | 285d | 2022-10-31 | 2023-11-17 |  |  | -0 | N/A | N/A | DBT | 5.0 | N/A | Design, Build & Test (PIT) |  |  |  |  |  |
| 335 | 1.3.6.4.2.5.1 | PIT Test Execution Progress Report |  | 39d | 2023-09-26 A | 2023-11-17 A | 327 | 100% |  | 2023-09-26 | 2023-11-17 | 39d | 2022-10-31 | 2023-11-10 |  |  |  | PP | SI Test | DBT | 5.0 |  | Design, Build & Test (PIT) | Complete | COMPLETE |  |  |  |
| 336 | 1.3.6.4.2.5.2 | PIT Execution |  | 40d | 2023-09-25 A | 2023-11-17 A | 332FS+5d | 100% |  | 2023-09-25 | 2023-11-17 | 275d | 2022-10-31 | 2023-11-17 |  |  |  | PP | SI Test | DBT | 5.0 |  | Design, Build & Test (PIT) | Complete | COMPLETE |  |  |  |
| 337 | 1.3.6.4.2.5.3 | All Metering Services PIT Completion Reports submitted to Programme for assurance | milestone | 0d | 2023-11-17 A | 2023-11-17 A | 335, 336 | 100% |  | 2023-11-17 | 2023-11-17 | 0d | 2024-01-05 | 2024-01-05 |  |  |  | PP | SI Test | DBT | 5.13 |  | Design, Build & Test (PIT) | Complete | COMPLETE | T3-DB-0137 | SITAG | T3 |
| 338 | 1.3.6.4.2.5.4 | All Metering Services PIT Completion Reports MHHS Review Completed | milestone | 0d | 2023-12-01 A | 2023-12-01 A | 325, 330, 333, 337FS+10d | 100% |  | 2023-12-01 | 2023-12-01 | 0d |  |  |  |  |  | SI Test | PP | DBT | 5.13 |  | Design, Build & Test (PIT) | Complete | COMPLETE | T3-DB-0138 | SITAG | T3 |
| 339 | 1.3.6.4.3 | **All SIT Programme Participants PIT (SIT Functional)** |  | 286d | 2023-11-17 A | 2024-12-20 |  | 77% | 66.66d | 2023-11-17 | 2024-12-20 | 451d | 2022-12-30 | 2024-02-16 | 125d |  | -0 | N/A | N/A | DBT | 5.0 | N/A | Design, Build & Test (PIT) |  |  |  |  |  |
| 340 | 1.3.6.4.3.1 | **Test Approach & Plans** |  | 40d | 2023-11-17 A | 2024-01-11 A |  | 100% |  | 2023-11-17 | 2024-01-11 | 40d | 2022-12-30 | 2023-11-30 |  |  | -0 | N/A | N/A | DBT | 5.2 | N/A | Design, Build & Test (PIT) |  |  |  |  |  |
| 341 | 1.3.6.4.3.1.1 | SIT Functional PIT Test Approach & Plan (PIT) submitted to Programme for assurance | milestone | 0d | 2023-11-17 A | 2023-11-17 A |  | 100% |  | 2023-11-17 | 2023-11-17 | 0d | 2023-11-16 | 2023-11-16 |  | start no earlier than 2023-11-17 |  | PP | SI Test | DBT | 5.16 |  | Design, Build & Test (PIT) | Complete | COMPLETE | T3-DB-0093 | SITAG | T3 |
| 342 | 1.3.6.4.3.1.2 | All SIT Functional Test approach and plans MHHS Reviews Completed | milestone | 0d | 2024-01-11 A | 2024-01-11 A | 341FS+40d | 100% |  | 2024-01-11 | 2024-01-11 | 0d | 2023-11-17 | 2023-11-30 |  |  |  | SI Test | PP | DBT | 5.8 |  | Design, Build & Test (PIT) | Complete | COMPLETE | T3-DB-0139 | SITAG | T3 |
| 343 | 1.3.6.4.3.2 | **Test Readiness Reports** |  | 11d | 2023-12-01 A | 2023-12-15 A |  | 100% |  | 2023-12-01 | 2023-12-15 | 51d | 2023-11-30 | 2024-02-08 |  |  |  | N/A | N/A | DBT | 5.2 | N/A | Design, Build & Test (PIT) |  |  |  |  |  |
| 344 | 1.3.6.4.3.2.1 | Test readiness reporting |  | 11d | 2023-12-01 A | 2023-12-15 A | 341FS+10d | 100% |  | 2023-12-01 | 2023-12-15 | 51d | 2023-11-30 | 2024-02-08 |  |  |  | PP | 109 | DBT | 5.2 |  | Design, Build & Test (PIT) | Complete | COMPLETE |  |  |  |
| 345 | 1.3.6.4.3.3 | **Requirements to test Traceability Matrices (RTTM)** |  | 30d | 2023-12-07 A | 2024-01-18 A |  | 100% |  | 2023-12-07 | 2024-01-18 | 30d | 2023-01-06 | 2024-01-05 |  |  | -0 | N/A | N/A | DBT | 5.2 | N/A | Design, Build & Test (PIT) |  |  |  |  |  |
| 346 | 1.3.6.4.3.3.1 | SIT Functional PIT RTTM submitted to Programme for assurance | milestone | 0d | 2023-12-07 A | 2023-12-07 A | 341FS+15d | 100% |  | 2023-12-07 | 2023-12-07 | 0d | 2023-12-14 | 2023-12-14 |  |  |  | PP | SI Test | DBT | 5.14 |  | Design, Build & Test (PIT) | Complete | COMPLETE | T3-DB-0091 | SITAG | T3 |
| 347 | 1.3.6.4.3.3.2 | All SIT Functional RTTMs MHHS Reviews Completed | milestone | 0d | 2024-01-18 A | 2024-01-18 A | 346FS+30d | 100% |  | 2024-01-18 | 2024-01-18 | 0d | 2023-12-15 | 2024-01-05 |  |  |  | SI Test | PP | DBT | 5.14 |  | Design, Build & Test (PIT) | Complete | COMPLETE | T3-DB-0140 | SITAG | T3 |
| 348 | 1.3.6.4.3.4 | **Test Scenarios** |  | 30d | 2023-12-07 A | 2024-01-18 A |  | 100% |  | 2023-12-07 | 2024-01-18 | 30d | 2023-01-06 | 2024-01-05 |  |  | -0 | N/A | N/A | DBT | 5.2 | N/A | Design, Build & Test (PIT) |  |  |  |  |  |
| 349 | 1.3.6.4.3.4.1 | SIT Functional PIT test scenarios submitted to Programme for assurance | milestone | 0d | 2023-12-07 A | 2023-12-07 A | 341FS+15d | 100% |  | 2023-12-07 | 2023-12-07 | 0d | 2023-12-14 | 2023-12-14 |  |  |  | PP | SI Test | DBT | 5.14 |  | Design, Build & Test (PIT) | Complete | COMPLETE | T3-DB-0089 | SITAG | T3 |
| 350 | 1.3.6.4.3.4.2 | All SIT Functional Test scenarios' MHHS Reviews Completed | milestone | 0d | 2024-01-18 A | 2024-01-18 A | 349FS+30d | 100% |  | 2024-01-18 | 2024-01-18 | 0d | 2023-12-15 | 2024-01-05 |  |  |  | SI Test | PP | DBT | 5.14 |  | Design, Build & Test (PIT) | Complete | COMPLETE | T3-DB-0141 | SITAG | T3 |
| 351 | 1.3.6.4.3.5 | **PIT execution** |  | 51d | 2023-12-15 A | 2024-02-23 A |  | 100% |  | 2023-12-15 | 2024-02-23 | 301d | 2022-12-30 | 2024-02-09 |  |  | -0 | N/A | N/A | DBT | 5.0 | N/A | Design, Build & Test (PIT) |  |  |  |  |  |
| 352 | 1.3.6.4.3.5.1 | PIT Test Execution Progress Reports |  | 40d | 2023-12-18 A | 2024-02-09 A | 344 | 100% |  | 2023-12-18 | 2024-02-09 | 40d | 2022-12-30 | 2024-02-01 |  |  |  | PP | SI Test | DBT | 5.0 |  | Design, Build & Test (PIT) | Complete | COMPLETE |  |  |  |
| 353 | 1.3.6.4.3.5.2 | PIT Execution |  | 41d | 2023-12-15 A | 2024-02-09 A | 349FS+5d | 100% |  | 2023-12-15 | 2024-02-09 | 290d | 2022-12-30 | 2024-02-09 |  |  |  | PP | SI Test | DBT | 5.0 |  | Design, Build & Test (PIT) | Complete | COMPLETE |  |  |  |
| 354 | 1.3.6.4.3.5.3 | All SIT Functional PIT Completion Reports submitted to Programme for Assurance | milestone | 0d | 2024-02-09 A | 2024-02-09 A | 352, 353 | 100% |  | 2024-02-09 | 2024-02-09 | 0d | 2024-01-05 | 2024-01-05 |  |  |  | PP | SI Test | DBT | 5.19 |  | Design, Build & Test (PIT) | Complete | COMPLETE | T3-DB-0087 | SITAG | T3 |
| 355 | 1.3.6.4.3.5.4 | All SIT Functional PIT Completion Reports MHHS Review Completed | milestone | 0d | 2024-02-23 A | 2024-02-23 A | 342, 347, 350, 354FS+10d | 100% |  | 2024-02-23 | 2024-02-23 | 0d |  |  |  |  |  | SI Test | PP | DBT | 5.19 |  | Design, Build & Test (PIT) | Complete | COMPLETE | T3-DB-0142 | SITAG | T3 |
| 356 | 1.3.6.4.3.6 | **All SIT Programme Participants PIT (SIT Migration)** |  | 71d | 2024-02-16 A | 2024-05-24 A |  | 100% |  | 2024-02-16 | 2024-05-24 | 301d |  |  |  |  | -0 | N/A | N/A | DBT | 5.1 | N/A | Design, Build & Test (PIT) |  |  |  |  |  |
| 357 | 1.3.6.4.3.6.1 | **Test Approach & Plans** |  | 40d | 2024-02-16 A | 2024-04-11 A |  | 100% |  | 2024-02-16 | 2024-04-11 | 40d |  |  |  |  | -0 | N/A | N/A | DBT | 5.2 | N/A | Design, Build & Test (PIT) |  |  |  |  |  |
| 358 | 1.3.6.4.3.6.1.1 | All SIT Migration PIT Test Approach & Plans submitted to Programme for assurance | milestone | 0d | 2024-02-16 A | 2024-02-16 A |  | 100% |  | 2024-02-16 | 2024-02-16 | 0d |  |  |  | start no earlier than 2024-02-16 |  | PP | SI Test | DBT | 5.8 |  | Design, Build & Test (PIT) | Complete | COMPLETE | T3-DB-0143 | SITAG | T3 |
| 359 | 1.3.6.4.3.6.1.2 | All SIT Migration PIT Test approach and plans MHHS Reviews Completed | milestone | 0d | 2024-04-11 A | 2024-04-11 A | 358FS+40d | 100% |  | 2024-04-11 | 2024-04-11 | 0d |  |  |  |  |  | SI Test | PP | DBT | 5.23 |  | Design, Build & Test (PIT) | Complete | COMPLETE | T3-DB-0144 | SITAG | T3 |

| ID | WBS | Task | Type | Duration | Start | Finish | Predecessors | Complete | Remaining | Baseline start | Baseline finish | Baseline duration | Baseline 1 start | Baseline 1 finish | Total slack | Free slack | Constraint | Baseline cost | Responsible | Involved | Text9 | Update Version | MHHS Resource Name | MHHS Programme Phase | Sched Status | RAG | Milestone ID | Text29 | Tier | Guidance | Task Status |
| --- | --- | --- | --- | --- | --- | --- | --- | --- | --- | --- | --- | --- | --- | --- | --- | --- | --- | --- | --- | --- | --- | --- | --- | --- | --- | --- | --- | --- | --- | --- | --- |
| 360 | 1.3.6.4.3.6.2 | **Test Readiness Reports** |  | 11d | 2024-03-01 A | 2024-03-15 A |  | 100% |  | 2024-03-01 | 2024-03-15 | 51d |  |  |  |  |  |  | N/A | N/A | DBT | 5.2 | N/A | Design, Build & Test (PIT) |  |  |  |  |  |  |  |
| 361 | 1.3.6.4.3.6.2.1 | Test readiness reporting |  | 11d | 2024-03-01 A | 2024-03-15 A | 358FS+10d | 100% |  | 2024-03-01 | 2024-03-15 | 51d |  |  |  |  |  |  | PP | 109 | DBT | 5.2 |  | Design, Build & Test (PIT) | Complete | COMPLETE |  |  |  |  |  |
| 362 | 1.3.6.4.3.6.3 | **Requirements to test Traceability Matrices (RTTM)** |  | 30d | 2024-03-07 A | 2024-04-18 A |  | 100% |  | 2024-03-07 | 2024-04-18 | 30d |  |  |  |  |  | -0 | N/A | N/A | DBT | 5.2 | N/A | Design, Build & Test (PIT) |  |  |  |  |  |  |  |
| 363 | 1.3.6.4.3.6.3.1 | All SIT Migration PIT RTTMs submitted to Programme for assurance | milestone | 0d | 2024-03-07 A | 2024-03-07 A | 358FS+15d | 100% |  | 2024-03-07 | 2024-03-07 | 0d |  |  |  |  |  |  | PP | SI Test | DBT | 5.23 |  | Design, Build & Test (PIT) | Complete | COMPLETE | T3-DB-0145 | SITAG | T3 |  |  |
| 364 | 1.3.6.4.3.6.3.2 | All SIT Migration RTTMs MHHS Reviews Completed | milestone | 0d | 2024-04-18 A | 2024-04-18 A | 363FS+30d | 100% |  | 2024-04-18 | 2024-04-18 | 0d |  |  |  |  |  |  | SI Test | PP | DBT | 5.25 |  | Design, Build & Test (PIT) | Complete | COMPLETE | T3-DB-0146 | SITAG | T3 |  |  |
| 365 | 1.3.6.4.3.6.4 | **Test Scenarios** |  | 30d | 2024-03-07 A | 2024-04-18 A |  | 100% |  | 2024-03-07 | 2024-04-18 | 30d |  |  |  |  |  | -0 | N/A | N/A | DBT | 5.2 | N/A | Design, Build & Test (PIT) |  |  |  |  |  |  |  |
| 366 | 1.3.6.4.3.6.4.1 | All SIT Migration PIT test scenarios submitted to Programme for assurance | milestone | 0d | 2024-03-07 A | 2024-03-07 A | 358FS+15d | 100% |  | 2024-03-07 | 2024-03-07 | 0d |  |  |  |  |  |  | PP | SI Test | DBT | 5.23 |  | Design, Build & Test (PIT) | Complete | COMPLETE | T3-DB-0147 | SITAG | T3 |  |  |
| 367 | 1.3.6.4.3.6.4.2 | All SIT Migration Test scenarios MHHS Reviews Completed | milestone | 0d | 2024-04-18 A | 2024-04-18 A | 366FS+30d | 100% |  | 2024-04-18 | 2024-04-18 | 0d |  |  |  |  |  |  | SI Test | PP | DBT | 5.25 |  | Design, Build & Test (PIT) | Complete | COMPLETE | T3-DB-0148 | SITAG | T3 |  |  |
| 368 | 1.3.6.4.3.6.5 | **PIT execution** |  | 51d | 2024-03-15 A | 2024-05-24 A |  | 100% |  | 2024-03-15 | 2024-05-24 | 301d |  |  |  |  |  | -0 | N/A | N/A | DBT | 5.1 | N/A | Design, Build & Test (PIT) |  |  |  |  |  |  |  |
| 369 | 1.3.6.4.3.6.5.1 | PIT Test Execution Progress Reports |  | 40d | 2024-03-18 A | 2024-05-10 A | 361 | 100% |  | 2024-03-18 | 2024-05-10 | 40d |  |  |  |  |  |  | PP | SI Test | DBT | 5.1 |  | Design, Build & Test (PIT) | Complete | COMPLETE |  |  |  |  |  |
| 370 | 1.3.6.4.3.6.5.2 | PIT Execution |  | 41d | 2024-03-15 A | 2024-05-10 A | 366FS+5d | 100% |  | 2024-03-15 | 2024-05-10 | 290d |  |  |  |  |  |  | PP | SI Test | DBT | 5.1 |  | Design, Build & Test (PIT) | Complete | COMPLETE |  |  |  |  |  |
| 371 | 1.3.6.4.3.6.5.3 | All SIT Migration PIT Completion Reports submitted to Programme for assurance | milestone | 0d | 2024-05-10 A | 2024-05-10 A | 369, 370 | 100% |  | 2024-05-10 | 2024-05-10 | 0d | 2024-01-05 | 2024-01-05 |  |  |  |  | PP | SI Test | DBT | 5.8 |  | Design, Build & Test (PIT) | Complete | COMPLETE | T3-DB-0149 | SITAG | T3 |  |  |
| 372 | 1.3.6.4.3.6.5.4 | All SIT Migration PIT Completion Reports MHHS Review Completed | milestone | 0d | 2024-05-24 A | 2024-05-24 A | 359, 364, 367, 371FS+10d | 100% |  | 2024-05-24 | 2024-05-24 | 0d |  |  |  |  |  |  | SI Test | PP | DBT | 5.8 |  | Design, Build & Test (PIT) | Complete | COMPLETE | T3-DB-0150 | SITAG | T3 |  |  |
| 373 | 1.3.6.4.3.7 | **All SIT Programme Participants PIT (SIT Non Functional)** |  | 116d | 2024-07-12 A | 2024-12-20 |  | 63% | 42.96d | 2024-07-12 | 2024-12-20 | 301d |  |  | 125d |  |  | -0 | N/A | N/A | DBT | 6.0 | N/A | Design, Build & Test (PIT) |  |  |  |  |  |  |  |
| 374 | 1.3.6.4.3.7.1 | **Test Approach & Plan** |  | 41d | 2024-09-27 A | 2024-11-22 |  |  | 41d | 2024-09-27 | 2024-11-22 | 40d |  |  | 145d |  |  | -0 | N/A | N/A | DBT | 6.0 | N/A | Design, Build & Test (PIT) |  |  |  |  |  |  |  |
| 375 | 1.3.6.4.3.7.1.1 | SIT Non-Functional PIT Test Approach & Plan (PIT) submitted to Programme for assurance | milestone | 0d | 2024-09-27 A | 2024-09-27 |  | 75% | 0d | 2024-09-27 | 2024-09-27 | 0d |  |  | 0d |  | start no earlier than 2024-05-10 |  | PP | SI Test | DBT | 6.0 | Roger Robar | Design, Build & Test (PIT) | Overdue | RED | T3-DB-0151 | SITAG | T3 |  |  |
| 376 | 1.3.6.4.3.7.1.2 | SIT Non-Functional Test approach and plan MHHS Review Completed |  | 1d | 2024-11-21 A | 2024-11-22 | 375FS+40d |  | 1d | 2024-11-21 | 2024-11-22 | 0d |  |  | 145d | 20d |  |  | SI Test | PP | DBT | 6.0 | Roger Robar | Design, Build & Test (PIT) | Green | GREEN | T3-DB-0152 | SITAG | T3 | 6/9/24: Approved at esitag on 26/7/24 | 21.33 |
| 377 | 1.3.6.4.3.7.2 | **Test Readiness Report** |  | 13d | 2024-10-04 A | 2024-10-22 |  | 85% | 2d | 2024-10-04 | 2024-10-22 | 51d |  |  | 0d |  |  |  | N/A | N/A | DBT | 6.0 | N/A | Design, Build & Test (PIT) |  |  |  |  |  |  |  |
| 378 | 1.3.6.4.3.7.2.1 | Test readiness reporting |  | 13d | 2024-10-04 A | 2024-10-22 | 375FS+10d | 85% | 2d | 2024-10-04 | 2024-10-22 | 51d |  |  | 0d |  |  |  | PP | 109 | DBT | 6.0 |  | Design, Build & Test (PIT) | Green | RED |  |  |  |  |  |
| 379 | 1.3.6.4.3.7.3 | **Requirements to test Traceability Matrix (RTTM)** |  | 20d | 2024-11-01 A | 2024-11-29 |  |  | 20d | 2024-11-01 | 2024-11-29 | 30d |  |  | 140d |  |  | -0 | N/A | N/A | DBT | 6.0 | N/A | Design, Build & Test (PIT) |  |  |  |  |  |  |  |
| 380 | 1.3.6.4.3.7.3.1 | SIT Non-Functional PIT RTTM submitted to Programme for assurance | milestone | 0d | 2024-11-01 A | 2024-11-01 | 375FS+26d | 75% | 0d | 2024-11-01 | 2024-11-01 | 0d |  |  | 140d | 0d |  |  | PP | SI Test | DBT | 6.0 | Roger Robar | Design, Build & Test (PIT) | Green | GREEN | T3-DB-0153 | SITAG | T3 |  |  |
| 381 | 1.3.6.4.3.7.3.2 | SIT Non-Functional RTTM MHHS Review Completed | milestone | 0d | 2024-11-29 | 2024-11-29 | 380FS+20d |  |  | 2024-11-29 | 2024-11-29 | 0d |  |  | 140d | 15d | start no earlier than 2024-11-29 |  | SI Test | PP | DBT | 6.0 | Roger Robar | Design, Build & Test (PIT) | Green | RED | T3-DB-0154 | SITAG | T3 |  | 29.71 |
| 382 | 1.3.6.4.3.7.4 | **Test Scenarios** |  | 20d | 2024-11-01 | 2024-11-29 |  |  |  | 2024-11-01 | 2024-11-29 | 30d |  |  | 0d |  |  | -0 | N/A | N/A | DBT | 6.0 | N/A | Design, Build & Test (PIT) |  |  |  |  |  |  |  |
| 383 | 1.3.6.4.3.7.4.1 | SIT Non-Functional PIT test scenarios submitted to Programme for assurance | milestone | 0d | 2024-11-01 | 2024-11-01 | 375FS+26d |  |  | 2024-11-01 | 2024-11-01 | 0d |  |  | 0d |  |  |  | PP | SI Test | DBT | 6.0 | Roger Robar | Design, Build & Test (PIT) | Green | GREEN | T3-DB-0155 | SITAG | T3 |  | 1.71 |
| 384 | 1.3.6.4.3.7.4.2 | SIT Non-Functional Test scenarios MHHS Review Completed | milestone | 0d | 2024-11-29 | 2024-11-29 | 383FS+20d |  |  | 2024-11-29 | 2024-11-29 | 0d |  |  | 140d | 15d |  |  | SI Test | PP | DBT | 6.0 | Roger Robar | Design, Build & Test (PIT) | Green | RED | T3-DB-0156 | SITAG | T3 |  | 29.71 |

Notes:
- 375: 34/34 initial plans have been submitted to the Programme, but still expecting revised plans from some PPs to address feedback given from the Programme, hence why this activity can't be completed yet. Because of the delay to all plans being submitted there is an increased risk to completion of SIT Non-Functional PIT. Re-forecasting the completion date isnt possible as delivery is dependent on the PPs.
- 376: 14/34 test approaches completed. Late because the completion of the review is dependant on the delivery of all of the SIT Non-Functional Test Approach and Plans from the PPs. This increases the risk to SIT Non-Functional PIT completion
- 380: 34/34 RTTMs have been submitted to the Programme. Because of the delay to all RTTMs being submitted there is an increased risk to completion of SIT Non-Functional PIT. Re-forecasting the completion date isnt possible as delivery is dependent on the PPs. Engagement taking place for remaining PPs.
- 381: 17/34 reviewed. As per T3-DB-0153, Status red until remaining RTTMs submitted and reviewed.
- 383: 33/34 test scenarios have been submitted to the Programme. Because of the delay to all test scenarios being submitted there is an increased risk to completion of SIT Non-Functional PIT. Re-forecasting the completion date isnt possible as delivery is depe
- 384: 17/34 scenarios have been completed. Date missed because the completion of the review is dependent on the delivery of all of the SIT Non-Functional Test Scenarios from the PPs. This increases the risk to SIT Non-Functional PIT completion

| ID | WBS | Task | Type | Duration | Start | Finish | Predecessors | Complete | Remaining | Baseline start | Baseline finish | Baseline duration | Baseline 1 start | Baseline 1 finish | Total slack | Free slack | Constraint | Baseline cost | Responsible | Involved | Text9 | Update Version | MHHS Resource Name | MHHS Programme Phase | Sched Status | RAG | Task Status | Milestone ID | Text29 | Tier |
| --- | --- | --- | --- | --- | --- | --- | --- | --- | --- | --- | --- | --- | --- | --- | --- | --- | --- | --- | --- | --- | --- | --- | --- | --- | --- | --- | --- | --- | --- | --- |
| 385 | 1.3.6.4.3.7.5 | **PIT execution** |  | 116d | 2024-07-12 A | 2024-12-20 |  | 61% | 45.66d | 2024-07-12 | 2024-12-20 | 301d |  |  | 125d |  |  | -0 | N/A | N/A | DBT | 6.0 | N/A | Design, Build & Test (PIT) |  |  |  |  |  |  |
| 386 | 1.3.6.4.3.7.5.1 | PIT Test Execution Progress Report |  | 50d | 2024-07-15 A | 2024-11-21 | 378 | 56% | 22d | 2024-07-15 | 2024-11-21 | 39d |  |  | 131d | 6d | finish no earlier than 2024-11-21 |  | PP | SI Test | DBT | 6.0 | Roger Robar | Design, Build & Test (PIT) | Green | GREEN |  |  |  |  |
| 387 | 1.3.6.4.3.7.5.2 | PIT Execution |  | 44d | 2024-07-12 A | 2024-11-29 | 383FS+5d | 66% | 15d | 2024-07-12 | 2024-11-29 | 290d |  |  | 125d | 0d | finish no earlier than 2024-11-29 |  | PP | SI Test | DBT | 6.0 | Roger Robar | Design, Build & Test (PIT) | Green | GREEN |  |  |  |  |
| 388 | 1.3.6.4.3.7.5.3 | SIT Non-Functional PIT Completion Report submitted to Programme for assurance | milestone | 0d | 2024-11-29 | 2024-11-29 | 386, 387 |  |  | 2024-11-29 | 2024-11-29 | 0d | 2024-01-05 | 2024-01-05 | 125d | 0d |  |  | PP | SI Test | DBT | 6.0 | Roger Robar | Design, Build & Test (PIT) | Green | GREEN | 29.71 | T3-DB-0157 | SITAG | T3 |
| 389 | 1.3.6.4.3.7.5.4 | SIT Non-Functional PIT Completion Report MHHS Review Completed | milestone | 0d | 2024-12-20 | 2024-12-20 | 376, 381, 384, 388FS+15d |  |  | 2024-12-20 | 2024-12-20 | 0d |  |  | 125d | 55d |  |  | SI Test | PP | DBT | 6.0 | Roger Robar | Design, Build & Test (PIT) | Green | GREEN | 50.71 | T3-DB-0158 | SITAG | T3 |
| 390 | 1.3.6.4.3.8 | **All SIT Programme Participants PIT (SIT Operational)** |  | 116d | 2024-07-12 A | 2024-12-20 |  | 46% | 62.41d | 2024-07-12 | 2024-12-20 | 71d |  |  | 87d |  |  | -0 | N/A | N/A | DBT | 6.0 | N/A | Design, Build & Test (PIT) |  |  |  |  |  |  |
| 391 | 1.3.6.4.3.8.1 | **Test Approach & Plan** |  | 40d | 2024-09-27 | 2024-11-21 |  |  |  | 2024-09-27 | 2024-11-21 | 40d |  |  | 0d |  |  | -0 | N/A | N/A | DBT | 6.0 | N/A | Design, Build & Test (PIT) |  |  |  |  |  |  |
| 392 | 1.3.6.4.3.8.1.1 | SIT Operational PIT Test Approach & Plan (PIT) submitted to Programme for assurance | milestone | 0d | 2024-09-27 | 2024-09-27 |  |  |  | 2024-09-27 | 2024-09-27 | 0d |  |  | 0d |  | start no earlier than 2024-09-27 |  | PP | SI Test | DBT | 6.0 | Roger Robar | Design, Build & Test (PIT) | Overdue Start | RED | -33.67 | T3-DB-0159 | SITAG | T3 |
| 393 | 1.3.6.4.3.8.1.2 | SIT Operational Test approach and plan MHHS Review Completed | milestone | 0d | 2024-11-21 | 2024-11-21 | 392FS+40d |  |  | 2024-11-21 | 2024-11-21 | 0d |  |  | 108d | 21d |  |  | SI Test | PP | DBT | 6.0 | Roger Robar | Design, Build & Test (PIT) | Green | AMBER | 21.71 | T3-DB-0160 | SITAG | T3 |
| 394 | 1.3.6.4.3.8.2 | **Test Readiness Report** |  | 13d | 2024-10-04 A | 2024-10-22 |  | 42% | 7.5d | 2024-10-04 | 2024-10-22 | 51d |  |  | 0d |  |  |  | N/A | N/A | DBT | 6.0 | N/A | Design, Build & Test (PIT) |  |  |  |  |  |  |
| 395 | 1.3.6.4.3.8.2.1 | Test readiness reporting |  | 13d | 2024-10-04 A | 2024-10-22 | 392FS+10d | 42% | 7.5d | 2024-10-04 | 2024-10-22 | 51d |  |  | 0d |  |  |  | PP | 109 | DBT | 6.0 |  | Design, Build & Test (PIT) | Green | GREEN |  |  |  |  |
| 396 | 1.3.6.4.3.8.3 | **Requirements to test Traceability Matrix (RTTM)** |  | 20d | 2024-11-01 | 2024-11-29 |  |  |  | 2024-11-01 | 2024-11-29 | 30d |  |  | 102d |  |  | -0 | N/A | N/A | DBT | 6.0 | N/A | Design, Build & Test (PIT) |  |  |  |  |  |  |
| 397 | 1.3.6.4.3.8.3.1 | SIT Operational PIT RTTM submitted to Programme for assurance | milestone | 0d | 2024-11-01 | 2024-11-01 | 392FS+26d |  |  | 2024-11-01 | 2024-11-01 | 0d |  |  | 102d | 0d |  |  | PP | SI Test | DBT | 6.0 | Roger Robar | Design, Build & Test (PIT) | Green | RED | 1.71 | T3-DB-0161 | SITAG | T3 |
| 398 | 1.3.6.4.3.8.3.2 | SIT Operational RTTM MHHS Review Completed | milestone | 0d | 2024-11-29 | 2024-11-29 | 397FS+20d |  |  | 2024-11-29 | 2024-11-29 | 0d |  |  | 102d | 15d |  |  | SI Test | PP | DBT | 6.0 | Roger Robar | Design, Build & Test (PIT) | Green | AMBER | 29.71 | T3-DB-0162 | SITAG | T3 |
| 399 | 1.3.6.4.3.8.4 | **Test Scenarios** |  | 20d | 2024-11-01 | 2024-11-29 |  |  |  | 2024-11-01 | 2024-11-29 | 30d |  |  | 0d |  |  | -0 | N/A | N/A | DBT | 6.0 | N/A | Design, Build & Test (PIT) |  |  |  |  |  |  |
| 400 | 1.3.6.4.3.8.4.1 | SIT Operational PIT test scenarios submitted to Programme for assurance | milestone | 0d | 2024-11-01 | 2024-11-01 | 392FS+26d |  |  | 2024-11-01 | 2024-11-01 | 0d |  |  | 0d |  |  |  | PP | SI Test | DBT | 6.0 | Roger Robar | Design, Build & Test (PIT) | Green | GREEN | 1.71 | T3-DB-0163 | SITAG | T3 |
| 401 | 1.3.6.4.3.8.4.2 | SIT Operational Test scenarios MHHS Review Completed | milestone | 0d | 2024-11-29 | 2024-11-29 | 400FS+20d |  |  | 2024-11-29 | 2024-11-29 | 0d |  |  | 102d | 15d |  |  | SI Test | PP | DBT | 6.0 | Roger Robar | Design, Build & Test (PIT) | Green | AMBER | 29.71 | T3-DB-0164 | SITAG | T3 |
| 402 | 1.3.6.4.3.8.5 | **PIT execution** |  | 116d | 2024-07-12 A | 2024-12-20 |  | 47% | 61.67d | 2024-07-12 | 2024-12-20 | 51d |  |  | 87d |  |  | -0 | N/A | N/A | DBT | 6.0 | N/A | Design, Build & Test (PIT) |  |  |  |  |  |  |
| 403 | 1.3.6.4.3.8.5.1 | PIT Test Execution Progress Report |  | 40d | 2024-07-15 A | 2024-11-21 | 395 | 45% | 22d | 2024-07-15 | 2024-11-21 | 40d |  |  | 93d | 6d |  |  | PP | SI Test | DBT | 6.0 | Roger Robar | Design, Build & Test (PIT) | Green | GREEN |  |  |  |  |
| 404 | 1.3.6.4.3.8.5.2 | PIT Execution |  | 39d | 2024-07-12 A | 2024-11-29 | 400 | 49% | 20d | 2024-07-12 | 2024-11-29 | 41d |  |  | 87d | 0d |  |  | PP | SI Test | DBT | 6.0 | Roger Robar | Design, Build & Test (PIT) | Green | GREEN |  |  |  |  |
| 405 | 1.3.6.4.3.8.5.3 | SIT Operational PIT Completion Report submitted to Programme for assurance | milestone | 0d | 2024-11-29 | 2024-11-29 | 403, 404 |  |  | 2024-11-29 | 2024-11-29 | 0d | 2024-01-05 | 2024-01-05 | 87d | 0d |  |  | PP | SI Test | DBT | 6.0 | Roger Robar | Design, Build & Test (PIT) | Green | RED | 29.71 | T3-DB-0165 | SITAG | T3 |
| 406 | 1.3.6.4.3.8.5.4 | SIT Operational PIT Completion Report MHHS Review Completed | milestone | 0d | 2024-12-20 | 2024-12-20 | 393, 398, 401, 405FS+15d |  |  | 2024-12-20 | 2024-12-20 | 0d |  |  | 87d | 0d |  |  | SI Test | PP | DBT | 6.0 | Roger Robar | Design, Build & Test (PIT) | Green | AMBER | 50.71 | T3-DB-0166 | SITAG | T3 |
| 407 | 1.3.6.4.4 | **All Suppliers DBT CIT (Entering at Interval 5)** |  | 71d | 2023-09-15 A | 2023-12-22 A |  | 100% |  | 2023-09-15 | 2023-12-22 | 300d | 2022-10-31 | 2025-03-14 |  |  |  | -0 | N/A | N/A | DBT | 6.0 | N/A | Design, Build & Test (PIT) |  |  |  |  |  |  |
| 408 | 1.3.6.4.4.1 | **Test Approach & Plan** |  | 20d | 2023-09-15 A | 2023-10-12 A |  | 100% |  | 2023-09-15 | 2023-10-12 | 19d | 2022-10-31 | 2023-09-29 |  |  |  | -0 | N/A | N/A | DBT | 6.0 | N/A | Design, Build & Test (PIT) |  |  |  |  |  |  |
| 409 | 1.3.6.4.4.1.1 | All SIT Suppliers Test Approach & Plans (PIT) submitted to Programme for assurance | milestone | 0d | 2023-09-15 A | 2023-09-15 A |  | 100% |  | 2023-09-15 | 2023-09-15 | 0d | 2023-09-15 | 2023-09-15 |  |  | start no earlier than 2023-09-15 |  | PP | SI Test | DBT | 6.0 |  | Design, Build & Test (PIT) | Complete | COMPLETE |  | T3-DB-0046 | SITAG | T3 |
| 410 | 1.3.6.4.4.1.2 | All SIT Suppliers Test Approach & Plans MHHS Review Completed | milestone | 0d | 2023-10-12 A | 2023-10-12 A | 409FS+20d | 100% |  | 2023-10-12 | 2023-10-12 | 0d | 2023-09-18 | 2023-09-29 |  |  |  |  | SI Test | PP | DBT | 6.0 |  | Design, Build & Test (PIT) | Complete | COMPLETE |  | T3-DB-0167 | SITAG | T3 |

Notes:
- 388: 22/34 SIT Non-Functional PIT Completion Reports have been submitted to the Programme. Because of the delay to all Completion Reports being submitted there is an increased risk to completion of SIT Operational PIT. Re-forecasting the completion date isnt possible as delivery is de
- 389: 4/34 reviewed. As per T3-DB-0157. Status red until remaining PIT Test Approach and Plans submitted and reviewed....
- 392: 32/34 test approach and plans have been submitted to the Programme. Because of the delay to all Test Approach and plans being submitted there is an increased risk to completion of SIT Operational PIT. Re-forecasting the completion date isnt possible as delivery is dependent~on the PPs. Engagement taking place for remaining PPs
- 393: 18/34 reviewed. As per T3-DB-0159, Status red until remaining PIT Test Approach and Plans submitted and reviewed.
- 397: 28/34 SIT Operational PIT RTTMs have been submitted to the Programme. Because of the delay to all RTTMs being submitted there is an increased risk to completion of SIT Operational PIT. Re-forecasting the completion date isnt possible as delivery is depen
- 398: 15/34 reviewed. As per T3-DB-0161. Status red until remaining PIT Test Approach and Plans submitted and reviewed....
- 400: 28/34 SIT Operational PIT test scenarios have been submitted to the Programme. Because of the delay to all SIT Operational PIT test scenarios being submitted there is increased risk to the completion of SIT Operational PIT.
- 401: 14/34 reviewed. As per T3-DB-0163. Status red until remaining PIT Test Approach and Plans submitted and reviewed.
- 405: 7/34 submitted. Date at risk because of potential delay to submissions for SIT Operational PIT completion reports. Impact may be a delay to the start of SIT Operational Testing. Programme continuting to work with PPs.
- 406: 0/34 Date missed because of potential delay to submissions for SIT Operational PIT completion reports. Continue engagement with PPs.

| ID | WBS | Task | Type | Duration | Start | Finish | Predecessors | Complete | Baseline start | Baseline finish | Baseline duration | Baseline 1 start | Baseline 1 finish | Constraint | Baseline cost | Responsible | Involved | Text9 | Update Version | MHHS Resource Name | MHHS Programme Phase | Sched Status | RAG | Artefact ID | Milestone ID | Text29 | Tier |
| --- | --- | --- | --- | --- | --- | --- | --- | --- | --- | --- | --- | --- | --- | --- | --- | --- | --- | --- | --- | --- | --- | --- | --- | --- | --- | --- | --- |
| 411 | 1.3.6.4.4.2 | **Test Readiness Report** |  | 11d | 2023-09-29 A | 2023-10-13 A |  | 100% | 2023-09-29 | 2023-10-13 | 51d | 2023-09-29 | 2023-12-08 |  |  | N/A | N/A | DBT | 6.0 | N/A | Design, Build & Test (PIT) |  |  |  |  |  |  |
| 412 | 1.3.6.4.4.2.1 | Test readiness reporting |  | 11d | 2023-09-29 A | 2023-10-13 A | 409FS+10d | 100% | 2023-09-29 | 2023-10-13 | 51d | 2023-09-29 | 2023-12-08 |  |  | PP | 109 | DBT | 6.0 |  | Design, Build & Test (PIT) | Complete | COMPLETE |  |  |  |  |
| 413 | 1.3.6.4.4.3 | **Requirements to test Traceability Matrix (RTTM)** |  | 20d | 2023-10-06 A | 2023-11-03 A |  | 100% | 2023-10-06 | 2023-11-03 | 21d | 2022-10-31 | 2023-10-20 |  | -0 | N/A | N/A | DBT | 6.0 | N/A | Design, Build & Test (PIT) |  |  |  |  |  |  |
| 414 | 1.3.6.4.4.3.1 | All SIT Suppliers RTTMs submitted to Programme for assurance | milestone | 0d | 2023-10-06 A | 2023-10-06 A | 409FS+16d | 100% | 2023-10-06 | 2023-10-06 | 1d | 2023-10-06 | 2023-10-06 |  |  | PP | SI Test | DBT | 6.0 |  | Design, Build & Test (PIT) | Complete | COMPLETE | MHHS-ART009 | T3-DB-0064 | SITAG | T3 |
| 415 | 1.3.6.4.4.3.2 | All SIT Suppliers RTTMs MHHS Review Completed | milestone | 0d | 2023-11-03 A | 2023-11-03 A | 414FS+20d | 100% | 2023-11-03 | 2023-11-03 | 0d | 2023-10-09 | 2023-10-20 |  |  | SI Test | PP | DBT | 6.0 |  | Design, Build & Test (PIT) | Complete | COMPLETE |  | T3-DB-0168 | SITAG | T3 |
| 416 | 1.3.6.4.4.4 | **Test Scenarios** |  | 20d | 2023-10-05 A | 2023-11-02 A |  | 100% | 2023-10-05 | 2023-11-02 | 20d | 2022-10-31 | 2023-10-20 |  | -0 | N/A | N/A | DBT | 6.0 | N/A | Design, Build & Test (PIT) |  |  |  |  |  |  |
| 417 | 1.3.6.4.4.4.1 | All SIT Suppliers test scenarios' submitted to Programme for assurance | milestone | 0d | 2023-10-05 A | 2023-10-05 A | 409FS+15d | 100% | 2023-10-05 | 2023-10-05 | 0d | 2023-10-06 | 2023-10-06 |  |  | PP | SI Test | DBT | 6.0 |  | Design, Build & Test (PIT) | Complete | COMPLETE |  | T3-DB-0037 | SITAG | T3 |
| 418 | 1.3.6.4.4.4.2 | All SIT Suppliers Test scenarios' MHHS Review Completed | milestone | 0d | 2023-11-02 A | 2023-11-02 A | 417FS+20d | 100% | 2023-11-02 | 2023-11-02 | 0d | 2023-10-09 | 2023-10-20 |  |  | SI Test | PP | DBT | 6.0 |  | Design, Build & Test (PIT) | Complete | COMPLETE |  | T3-DB-0169 | SITAG | T3 |
| 419 | 1.3.6.4.4.5 | **PIT execution** |  | 51d | 2023-10-13 A | 2023-12-22 A |  | 100% | 2023-10-13 | 2023-12-22 | 300d | 2022-10-31 | 2023-12-08 |  | -0 | N/A | N/A | DBT | 6.0 | N/A | Design, Build & Test (PIT) |  |  |  |  |  |  |
| 420 | 1.3.6.4.4.5.1 | PIT Test Execution Progress Report |  | 40d | 2023-10-16 A | 2023-12-08 A | 417FS+5d, 412 | 100% | 2023-10-16 | 2023-12-08 | 40d | 2022-10-31 | 2023-12-01 |  |  | PP | SI Test | DBT | 6.0 |  | Design, Build & Test (PIT) | Complete | COMPLETE |  |  |  |  |
| 421 | 1.3.6.4.4.5.2 | PIT Execution |  | 41d | 2023-10-13 A | 2023-12-08 A | 417FS+5d | 100% | 2023-10-13 | 2023-12-08 | 290d | 2022-10-31 | 2023-12-08 |  |  | PP | SI Test | DBT | 6.0 |  | Design, Build & Test (PIT) | Complete | COMPLETE |  |  |  |  |
| 422 | 1.3.6.4.4.5.3 | All SIT Suppliers PIT Completion Reports submitted to Programme for assurance | milestone | 0d | 2023-12-08 A | 2023-12-08 A | 421, 420 | 100% | 2023-12-08 | 2023-12-08 | 0d | 2024-01-05 | 2024-01-05 |  |  | PP | SI Test | DBT | 6.0 |  | Design, Build & Test (PIT) | Complete | COMPLETE |  | T3-DB-0170 | SITAG | T3 |
| 423 | 1.3.6.4.4.5.4 | All SIT Suppliers PIT Completion Reports MHHS Review Completed | milestone | 0d | 2023-12-22 A | 2023-12-22 A | 422FS+10d, 410, 415, 418 | 100% | 2023-12-22 | 2023-12-22 | 0d |  |  |  |  | SI Test | PP | DBT | 6.0 |  | Design, Build & Test (PIT) | Complete | COMPLETE |  | T3-DB-0171 | SITAG | T3 |
| 424 | 1.3.6.4.5 | **All LDSO Network Operations DBT CIT (Entering at Interval 5)** |  | 71d | 2023-09-15 A | 2023-12-22 A |  | 100% | 2023-09-15 | 2023-12-22 | 310d | 2022-10-31 | 2025-03-14 |  | -0 | N/A | N/A | DBT | 5.0 | N/A | Design, Build & Test (PIT) |  |  |  |  |  |  |
| 425 | 1.3.6.4.5.1 | **Test Approach & Plan** |  | 71d | 2023-09-15 A | 2023-12-22 A |  | 100% | 2023-09-15 | 2023-12-22 | 310d | 2022-10-31 | 2023-08-11 |  | -0 | N/A | N/A | DBT | 5.0 | N/A | Design, Build & Test (PIT) |  |  |  |  |  |  |
| 426 | 1.3.6.4.5.1.1 | All Network Operation Test Approach & Plans (PIT) submitted to Programme for assurance | milestone | 0d | 2023-09-15 A | 2023-09-15 A |  | 100% | 2023-09-15 | 2023-09-15 | 0d | 2023-07-28 | 2023-07-28 | start no earlier than 2023-09-15 |  | PP | SI Test | DBT | 5.8 |  | Design, Build & Test (PIT) | Complete | COMPLETE |  | T3-DB-0054 | SITAG | T3 |
| 427 | 1.3.6.4.5.1.2 | All Network Operation Test Approach & Plans MHHS Review Completed | milestone | 0d | 2023-10-12 A | 2023-10-12 A | 426FS+20d | 100% | 2023-10-12 | 2023-10-12 | 0d | 2023-07-31 | 2023-08-11 |  |  | SI Test | PP | DBT | 5.8 |  | Design, Build & Test (PIT) | Complete | COMPLETE |  | T3-DB-0172 | SITAG | T3 |
| 428 | 1.3.6.4.5.1.3 | **Test Readiness Report** |  | 11d | 2023-09-29 A | 2023-10-13 A |  | 100% | 2023-09-29 | 2023-10-13 | 51d | 2023-08-11 | 2023-10-20 |  |  | N/A | N/A | DBT | 5.0 | N/A | Design, Build & Test (PIT) |  |  |  |  |  |  |
| 429 | 1.3.6.4.5.1.3.1 | Test readiness reporting |  | 11d | 2023-09-29 A | 2023-10-13 A | 426FS+10d | 100% | 2023-09-29 | 2023-10-13 | 51d | 2023-08-11 | 2023-10-20 |  |  | PP | 109 | DBT | 5.0 |  | Design, Build & Test (PIT) | Complete | COMPLETE |  |  |  |  |
| 430 | 1.3.6.4.5.1.4 | **Requirements to test Traceability Matrix (RTTM)** |  | 20d | 2023-10-05 A | 2023-11-02 A |  | 100% | 2023-10-05 | 2023-11-02 | 20d | 2022-10-31 | 2023-09-15 |  | -0 | N/A | N/A | DBT | 5.0 | N/A | Design, Build & Test (PIT) |  |  |  |  |  |  |
| 431 | 1.3.6.4.5.1.4.1 | All Network Operation RTTMs submitted to Programme for assurance | milestone | 0d | 2023-10-05 A | 2023-10-05 A | 426FS+15d | 100% | 2023-10-05 | 2023-10-05 | 0d | 2023-09-01 | 2023-09-01 | start no earlier than 2023-04-28 |  | PP | SI Test | DBT | 5.8 |  | Design, Build & Test (PIT) | Complete | COMPLETE | MHHS-ART009 | T3-DB-0062 | SITAG | T3 |
| 432 | 1.3.6.4.5.1.4.2 | All Network Operation RTTMs MHHS Review Completed | milestone | 0d | 2023-11-02 A | 2023-11-02 A | 431FS+20d | 100% | 2023-11-02 | 2023-11-02 | 0d | 2023-09-04 | 2023-09-15 |  |  | SI Test | PP | DBT | 5.14 |  | Design, Build & Test (PIT) | Complete | COMPLETE |  | T3-DB-0173 | SITAG | T3 |
| 433 | 1.3.6.4.5.1.5 | **Test Scenarios** |  | 20d | 2023-10-05 A | 2023-11-02 A |  | 100% | 2023-10-05 | 2023-11-02 | 20d | 2022-10-31 | 2023-09-15 |  | -0 | N/A | N/A | DBT | 5.0 | N/A | Design, Build & Test (PIT) |  |  |  |  |  |  |
| 434 | 1.3.6.4.5.1.5.1 | All Network Operation test scenarios' submitted to Programme for assurance | milestone | 0d | 2023-10-05 A | 2023-10-05 A | 426FS+15d | 100% | 2023-10-05 | 2023-10-05 | 0d | 2023-09-01 | 2023-09-01 |  |  | PP | SI Test | DBT | 5.8 |  | Design, Build & Test (PIT) | Complete | COMPLETE |  | T3-DB-0011 | SITAG | T3 |
| 435 | 1.3.6.4.5.1.5.2 | All Network Operation test scenarios' MHHS Review Completed | milestone | 0d | 2023-11-02 A | 2023-11-02 A | 434FS+20d | 100% | 2023-11-02 | 2023-11-02 | 0d | 2023-09-04 | 2023-09-15 |  |  | SI Test | PP | DBT | 5.14 |  | Design, Build & Test (PIT) | Complete | COMPLETE |  | T3-DB-0174 | SITAG | T3 |

| ID | WBS | Task | Type | Duration | Start | Finish | Predecessors | Complete | Remaining | Actual start | Actual finish | Baseline start | Baseline finish | Baseline duration | Baseline 1 start | Baseline 1 finish | Total slack | Constraint | Baseline cost | Responsible | Involved | Text9 | Update Version | MHHS Resource Name | MHHS Programme Phase | Sched Status | RAG | Milestone ID | Text29 | Tier | Artefact ID | Task Status |
| --- | --- | --- | --- | --- | --- | --- | --- | --- | --- | --- | --- | --- | --- | --- | --- | --- | --- | --- | --- | --- | --- | --- | --- | --- | --- | --- | --- | --- | --- | --- | --- | --- |
| 436 | 1.3.6.4.5.1.6 | **PIT execution** |  | 51d | 2023-10-13 A | 2023-12-22 A |  | 100% |  |  |  | 2023-10-13 | 2023-12-22 | 310d | 2022-10-31 | 2024-01-05 |  |  | -0 | N/A | N/A | DBT | 5.0 | N/A | Design, Build & Test (PIT) |  |  |  |  |  |  |  |
| 437 | 1.3.6.4.5.1.6.1 | PIT Test Execution Progress Report |  | 40d | 2023-10-16 A | 2023-12-08 A | 434FS+5d, 429 | 100% |  |  |  | 2023-10-16 | 2023-12-08 | 305d | 2022-10-31 | 2023-12-29 |  |  |  | PP | SI Test | DBT | 5.0 |  | Design, Build & Test (PIT) | Complete | COMPLETE |  |  |  |  |  |
| 438 | 1.3.6.4.5.1.6.2 | PIT Execution |  | 41d | 2023-10-13 A | 2023-12-08 A | 434FS+5d | 100% |  |  |  | 2023-10-13 | 2023-12-08 | 310d | 2022-10-31 | 2024-01-05 |  |  |  | PP | SI Test | DBT | 5.0 |  | Design, Build & Test (PIT) | Complete | COMPLETE |  |  |  |  |  |
| 439 | 1.3.6.4.5.1.6.3 | All Network Operation PIT (CIT interval 5) Completion Reports submitted to Programme for assurance | milestone | 0d | 2023-12-08 A | 2023-12-08 A | 438, 437 | 100% |  |  |  | 2023-12-08 | 2023-12-08 | 0d | 2024-01-05 | 2024-01-05 |  |  |  | PP | SI Test | DBT | 5.0 |  | Design, Build & Test (PIT) | Complete | COMPLETE | T3-DB-0175 | SITAG | T3 |  |  |
| 440 | 1.3.6.4.5.1.6.4 | All Network Operation PIT (CIT interval 5) Completion Reports MHHS Review Completed | milestone | 0d | 2023-12-22 A | 2023-12-22 A | 439FS+10d, 427, 432, 435 | 100% |  |  |  | 2023-12-22 | 2023-12-22 | 0d |  |  |  |  |  | SI Test | PP | DBT | 5.15 |  | Design, Build & Test (PIT) | Complete | COMPLETE | T3-DB-0176 | SITAG | T3 |  |  |
| 441 | 1.3.6.4.6 | **All UMSO DBT CIT (Entering at Interval 6)** |  | 81d | 2023-09-29 | 2024-01-19 A |  | 100% |  | 2023-10-13 |  | 2023-09-29 | 2024-01-19 | 320d | 2022-10-31 | 2024-05-13 |  |  | -0 | N/A | N/A | DBT | 5.0 | N/A | Design, Build & Test (PIT) |  |  |  |  |  |  |  |
| 442 | 1.3.6.4.6.1 | **Test Approach & Plan** |  | 20d | 2023-10-13 A | 2023-11-09 A |  | 100% |  |  |  | 2023-10-13 | 2023-11-09 | 40d | 2022-10-31 | 2023-09-29 |  |  | -0 | N/A | N/A | DBT | 5.0 | N/A | Design, Build & Test (PIT) |  |  |  |  |  |  |  |
| 443 | 1.3.6.4.6.1.1 | All UMSO Test Approach & Plans (PIT) submitted to Programme for assurance | milestone | 0d | 2023-10-13 A | 2023-10-13 A |  | 100% |  |  |  | 2023-10-13 | 2023-10-13 | 0d | 2023-09-15 | 2023-09-15 |  | start no earlier than 2023-10-13 |  | PP | SI Test | DBT | 5.11 |  | Design, Build & Test (PIT) | Complete | COMPLETE | T3-DB-0052 | SITAG | T3 |  |  |
| 444 | 1.3.6.4.6.1.2 | All UMSO Test Approach & Plans MHHS Review Completed | milestone | 0d | 2023-11-09 A | 2023-11-09 A | 443FS+20d | 100% |  |  |  | 2023-11-09 | 2023-11-09 | 0d | 2023-09-18 | 2023-09-29 |  |  |  | SI Test | PP | DBT | 5.10 |  | Design, Build & Test (PIT) | Complete | COMPLETE | T3-DB-0177 | SITAG | T3 |  |  |
| 445 | 1.3.6.4.6.2 | **Test Readiness Report** |  | 11d | 2023-09-29 | 2023-10-13 |  | 100% |  | 2023-10-27 | 2023-11-10 | 2023-09-29 | 2023-10-13 | 11d | 2023-09-29 | 2023-12-08 |  |  | -0 | N/A | N/A | DBT | 5.0 | N/A | Design, Build & Test (PIT) |  |  |  |  |  |  |  |
| 446 | 1.3.6.4.6.2.1 | Test readiness reporting |  | 11d | 2023-10-27 A | 2023-11-10 A | 443FS+10d | 100% |  |  |  | 2023-10-27 | 2023-11-10 | 11d | 2023-09-29 | 2023-12-08 |  |  |  | PP | 109 | DBT | 5.0 |  | Design, Build & Test (PIT) | Complete | COMPLETE |  |  |  |  |  |
| 447 | 1.3.6.4.6.3 | **Requirements to test Traceability Matrix (RTTM)** |  | 20d | 2023-10-05 | 2023-11-01 |  | 100% |  | 2023-11-02 | 2023-11-30 | 2023-10-05 | 2023-11-01 | 20d | 2022-10-31 | 2023-10-20 |  |  | -0 | N/A | N/A | DBT | 5.0 | N/A | Design, Build & Test (PIT) |  |  |  |  |  |  |  |
| 448 | 1.3.6.4.6.3.1 | All UMSO RTTMs submitted to Programme for assurance | milestone | 0d | 2023-11-02 A | 2023-11-02 A | 443FS+15d | 100% |  |  |  | 2023-11-02 | 2023-11-02 | 0d | 2023-10-06 | 2023-10-06 |  |  |  | PP | SI Test | DBT | 5.12 |  | Design, Build & Test (PIT) | Complete | COMPLETE | T3-DB-0060 | SITAG | T3 | MHHS-ART009 |  |
| 449 | 1.3.6.4.6.3.2 | All UMSO RTTMs MHHS Review Completed | milestone | 0d | 2023-11-30 A | 2023-11-30 A | 448FS+20d | 100% |  |  |  | 2023-11-30 | 2023-11-30 | 0d | 2023-10-09 | 2023-10-20 |  |  |  | SI Test | PP | DBT | 5.12 |  | Design, Build & Test (PIT) | Complete | COMPLETE | T3-DB-0178 | SITAG | T3 |  |  |
| 450 | 1.3.6.4.6.4 | **Test Scenarios** |  | 20d | 2023-10-05 | 2023-11-01 |  | 100% |  | 2023-11-02 | 2023-11-30 | 2023-10-05 | 2023-11-01 | 20d | 2022-10-31 | 2023-10-20 |  |  | -0 | N/A | N/A | DBT | 5.0 | N/A | Design, Build & Test (PIT) |  |  |  |  |  |  |  |
| 451 | 1.3.6.4.6.4.1 | All UMSO test scenarios' submitted to Programme for assurance | milestone | 0d | 2023-11-02 A | 2023-11-02 A | 443FS+15d | 100% |  |  |  | 2023-11-02 | 2023-11-02 | 0d | 2023-10-06 | 2023-10-06 |  |  |  | PP | SI Test | DBT | 5.12 |  | Design, Build & Test (PIT) | Complete | COMPLETE | T3-DB-0025 | SITAG | T3 |  |  |
| 452 | 1.3.6.4.6.4.2 | All UMSO Test scenarios' MHHS Review Completed | milestone | 0d | 2023-11-30 A | 2023-11-30 A | 451FS+20d | 100% |  |  |  | 2023-11-30 | 2023-11-30 | 0d | 2023-10-09 | 2023-10-20 |  |  |  | SI Test | PP | DBT | 5.10 |  | Design, Build & Test (PIT) | Complete | COMPLETE | T3-DB-0179 | SITAG | T3 |  |  |
| 453 | 1.3.6.4.6.5 | **PIT execution** |  | 51d | 2023-11-10 A | 2024-01-19 A |  | 100% |  |  |  | 2023-11-10 | 2024-01-19 | 320d | 2022-10-31 | 2023-12-08 |  |  | -0 | N/A | N/A | DBT | 5.0 | N/A | Design, Build & Test (PIT) |  |  |  |  |  |  |  |
| 454 | 1.3.6.4.6.5.1 | PIT Test Execution Progress Report |  | 40d | 2023-11-13 A | 2024-01-05 A | 451FS+5d, 446 | 100% |  |  |  | 2023-11-13 | 2024-01-05 | 40d | 2022-10-31 | 2023-12-01 |  |  |  | PP | SI Test | DBT | 5.0 |  | Design, Build & Test (PIT) | Complete | COMPLETE |  |  |  |  |  |
| 455 | 1.3.6.4.6.5.2 | PIT Execution |  | 40d | 2023-11-10 A | 2024-01-04 A | 451FS+5d | 100% |  |  |  | 2023-11-10 | 2024-01-04 | 290d | 2022-10-31 | 2023-12-08 |  |  |  | PP | SI Test | DBT | 5.0 |  | Design, Build & Test (PIT) | Complete | COMPLETE |  |  |  |  |  |
| 456 | 1.3.6.4.6.5.3 | All UMSO PIT (CIT interval 6) Completion Reports submitted to Programme for assurance | milestone | 0d | 2024-01-05 A | 2024-01-05 A | 455, 454 | 100% |  |  |  | 2024-01-05 | 2024-01-05 | 0d | 2024-01-05 | 2024-01-05 |  |  |  | PP | SI Test | DBT | 5.10 |  | Design, Build & Test (PIT) | Complete | COMPLETE | T3-DB-0180 | SITAG | T3 |  |  |
| 457 | 1.3.6.4.6.5.4 | All UMSO PIT (CIT interval 6) Completion Reports MHHS Review Completed | milestone | 0d | 2024-01-19 A | 2024-01-19 A | 444, 449, 452, 456FS+10d | 100% |  |  |  | 2024-01-19 | 2024-01-19 | 0d |  |  |  |  |  | SI Test | PP | DBT | 5.10 |  | Design, Build & Test (PIT) | Complete | COMPLETE | T3-DB-0181 | SITAG | T3 |  |  |
| 458 | 1.3.7 | **DBT Monitoring and Assurance** |  | 842d | 2022-10-31 A | 2026-01-20 |  | 69% | 262.62d |  |  | 2022-10-31 | 2026-01-20 | 842d | 2022-10-31 | 2026-01-19 | 502d |  |  | N/A | N/A | DBT | 5.0 | N/A | Design, Build & Test (PIT) |  |  |  |  |  |  |  |
| 459 | 1.3.7.1 | **Planning and DBT Progress Monitoring of PPs** |  | 696d | 2022-10-31 A | 2025-06-30 |  | 67% | 233d |  |  | 2022-10-31 | 2025-06-30 | 696d | 2022-10-31 | 2025-06-30 | 648d |  |  | N/A | N/A | DBT | 5.0 | N/A | Design, Build & Test (PIT) |  |  |  |  |  |  | M9 |
| 460 | 1.3.7.1.1 | Monitor Non-SIT PPs Planning and DBT1 progress (to inform confirmation of Qualification Testing Tranche participants milestones) |  | 696d | 2022-10-31 A | 2025-06-30 | 173SS | 67% | 233d |  |  | 2022-10-31 | 2025-06-30 | 696d | 2022-10-31 | 2025-06-30 | 648d |  |  | Code Bodies | SI Test,PPC | DBT | 5.0 | Roger Robar | Design, Build & Test (PIT) | Green | GREEN |  |  |  |  |  |

Notes:
- 460: 15/9 - hold in plan until qualification sections updated

| ID | WBS | Task | Type | Duration | Start | Finish | Predecessors | Complete | Remaining | Baseline start | Baseline finish | Baseline duration | Baseline 1 start | Baseline 1 finish | Total slack | Constraint | Responsible | Involved | Text9 | Task Status | Update Version | MHHS Resource Name | MHHS Programme Phase | Sched Status | RAG | Milestone ID | Text29 | Tier | Artefact ID |
| --- | --- | --- | --- | --- | --- | --- | --- | --- | --- | --- | --- | --- | --- | --- | --- | --- | --- | --- | --- | --- | --- | --- | --- | --- | --- | --- | --- | --- | --- |
| 461 | 1.3.7.2 | **DBT Progress Monitoring of Consequential Change** |  | 774d | 2023-02-02 A | 2026-01-20 |  | 51% | 379d | 2023-02-02 | 2026-01-20 | 774d | 2023-02-01 | 2026-01-19 | 502d |  | N/A | N/A | DBT | M9 | 5.0 | N/A | Design, Build & Test (PIT) |  |  |  |  |  |  |
| 462 | 1.3.7.2.1 | Monitor & report data cleanse progress |  | 774d | 2023-02-02 A | 2026-01-20 |  | 51% | 379d | 2023-02-02 | 2026-01-20 | 774d | 2023-02-01 | 2026-01-19 | 502d |  | SI Test | PPC | DBT |  | 5.0 | Matthew Breen | Design, Build & Test (PIT) | Green | GREEN |  |  |  |  |
| 463 | 1.3.7.3 | **Design Assurance** |  | 713d | 2022-11-14 A | 2025-08-06 |  | 80% | 142.32d | 2022-11-14 | 2025-08-06 | 713d | 2022-11-14 | 2025-08-06 | 621d |  | N/A | N/A | DBT | M9 | 5.0 | N/A | Design, Build & Test (PIT) |  |  |  |  |  |  |
| 464 | 1.3.7.3.1 | **Design Assurance Readiness Assessment Preparation** |  | 39d | 2023-02-28 A | 2023-04-21 A |  | 100% |  | 2023-02-28 | 2023-04-21 | 39d | 2023-02-28 | 2023-04-21 |  |  | N/A | N/A | DBT |  | 5.0 | N/A | Design, Build & Test (PIT) |  |  |  |  |  |  |
| 465 | 1.3.7.3.1.1 | Set up FTIG |  | 15d | 2023-04-03 A | 2023-04-21 A |  | 100% |  | 2023-04-03 | 2023-04-21 | 15d | 2023-04-03 | 2023-04-21 |  | must start on 2023-04-03 | SI Design |  | DBT |  | 5.0 | Paul Pettitt | Design, Build & Test (PIT) | Complete | COMPLETE |  |  |  |  |
| 466 | 1.3.7.3.1.2 | Produce Draft Questions |  | 10d | 2023-02-28 A | 2023-03-13 A |  | 100% |  | 2023-02-28 | 2023-03-13 | 10d | 2023-02-28 | 2023-03-13 |  | must start on 2023-02-28 | SI Design |  | DBT |  | 5.0 | Paul Pettitt | Design, Build & Test (PIT) | Complete | COMPLETE |  |  |  |  |
| 467 | 1.3.7.3.1.3 | Pilot with SRO |  | 1d | 2023-03-14 A | 2023-03-14 A | 466 | 100% |  | 2023-03-14 | 2023-03-14 | 1d | 2023-03-14 | 2023-03-14 |  |  | SI Design |  | DBT |  | 5.0 | Paul Pettitt | Design, Build & Test (PIT) | Complete | COMPLETE |  |  |  |  |
| 468 | 1.3.7.3.1.4 | Finalise questions |  | 10d | 2023-03-15 A | 2023-03-28 A | 467 | 100% |  | 2023-03-15 | 2023-03-28 | 10d | 2023-03-15 | 2023-03-28 |  |  | SI Design |  | DBT |  | 5.0 | Paul Pettitt | Design, Build & Test (PIT) | Complete | COMPLETE |  |  |  |  |
| 469 | 1.3.7.3.1.5 | Prepare on-line RA tooling |  | 10d | 2023-03-29 A | 2023-04-11 A | 468 | 100% |  | 2023-03-29 | 2023-04-11 | 10d | 2023-03-29 | 2023-04-11 |  |  | SI Design |  | DBT |  | 5.0 | Paul Pettitt | Design, Build & Test (PIT) | Complete | COMPLETE |  |  |  |  |
| 470 | 1.3.7.3.1.6 | Prepare webinar content |  | 5d | 2023-03-20 A | 2023-03-24 A | 466FS+4d | 100% |  | 2023-03-20 | 2023-03-24 | 5d | 2023-03-20 | 2023-03-24 |  |  | SI Design |  | DBT |  | 5.0 | Paul Pettitt | Design, Build & Test (PIT) | Complete | COMPLETE |  |  |  |  |
| 471 | 1.3.7.3.1.7 | Conduct webinar |  | 1d | 2023-03-30 A | 2023-03-30 A | 470FS+3d | 100% |  | 2023-03-30 | 2023-03-30 | 1d | 2023-03-30 | 2023-03-30 |  |  | SI Design | PP | DBT |  | 5.0 | Paul Pettitt | Design, Build & Test (PIT) | Complete | COMPLETE |  |  |  |  |
| 472 | 1.3.7.3.2 | **Participant Design Assurance Approach** |  | 43d | 2022-11-14 A | 2023-01-11 A |  | 100% |  | 2022-11-14 | 2023-01-11 | 43d | 2022-11-14 | 2023-01-11 |  |  | N/A | N/A | DBT |  | 5.0 | N/A | Design, Build & Test (PIT) |  |  |  |  |  |  |
| 473 | 1.3.7.3.2.1 | Develop document |  | 20d | 2022-11-14 A | 2022-12-09 A | 47FS+10d | 100% |  | 2022-11-14 | 2022-12-09 | 20d | 2022-11-14 | 2022-12-09 |  | start no earlier than 2022-11-14 | SI Design | PP | DBT |  | 5.0 | Paul Pettitt | Design, Build & Test (PIT) | Complete | COMPLETE |  |  |  |  |
| 474 | 1.3.7.3.2.2 | Review document |  | 18d | 2022-12-12 A | 2023-01-04 A | 473 | 100% |  | 2022-12-12 | 2023-01-04 | 18d | 2022-12-12 | 2023-01-04 |  |  | PP | SI Design,IPA | DBT |  | 5.0 | Paul Pettitt | Design, Build & Test (PIT) | Complete | COMPLETE |  |  |  |  |
| 475 | 1.3.7.3.2.3 | Participant Design Assurance Approach approved | milestone | 0d | 2023-01-11 A | 2023-01-11 A | 474FF+5d | 100% |  | 2023-01-11 | 2023-01-11 | 0d | 2023-01-11 | 2023-01-11 |  |  | SI Design | PP | DBT |  | 5.0 | Paul Pettitt | Design, Build & Test (PIT) | Complete | COMPLETE | T3-DB-0012 | DAG | T3 |  |
| 476 | 1.3.7.3.3 | **Phase 1 - SIT Volunteers (Core Providers)** |  | 145d | 2023-04-10 A | 2023-10-27 A |  | 100% |  | 2023-04-10 | 2023-10-27 | 145d | 2023-04-10 | 2023-10-27 |  |  | N/A | N/A | DBT |  | 5.0 | N/A | Design, Build & Test (PIT) |  |  |  |  |  |  |
| 477 | 1.3.7.3.3.1 | Send on-line questionnaire to core capability providers and current SIT volunteers (from Round 3 consultation) |  | 1d | 2023-04-10 A | 2023-04-10 A |  | 100% |  | 2023-04-10 | 2023-04-10 | 1d | 2023-04-10 | 2023-04-10 |  | must start on 2023-04-10 | SI Design | PP | DBT |  | 5.0 | Paul Pettitt | Design, Build & Test (PIT) | Complete | COMPLETE |  |  |  |  |
| 478 | 1.3.7.3.3.2 | Participants Provide Responses to questionnaires |  | 15d | 2023-04-11 A | 2023-05-01 A | 477 | 100% |  | 2023-04-11 | 2023-05-01 | 15d | 2023-04-11 | 2023-05-01 |  |  | PP |  | DBT |  | 5.0 | Paul Pettitt | Design, Build & Test (PIT) | Complete | COMPLETE |  |  |  |  |
| 479 | 1.3.7.3.3.3 | Assess on-line responses and provided evidence |  | 5d | 2023-05-02 A | 2023-05-08 A | 478 | 100% |  | 2023-05-02 | 2023-05-08 | 5d | 2023-05-02 | 2023-05-08 |  |  | SI Design |  | DBT |  | 5.0 | Paul Pettitt | Design, Build & Test (PIT) | Complete | COMPLETE |  |  |  |  |
| 480 | 1.3.7.3.3.4 | Bi-lateral meeting with each responder, to walk and navigate through provided materials |  | 31d | 2023-05-09 A | 2023-06-20 A | 479 | 100% |  | 2023-05-09 | 2023-06-20 | 31d | 2023-05-09 | 2023-06-20 |  |  | SI Design | PP | DBT |  | 5.0 | Paul Pettitt | Design, Build & Test (PIT) | Complete | COMPLETE |  |  |  |  |
| 481 | 1.3.7.3.3.5 | Plan for, create and execute deep dive assurance interviews based on agreed priorities (participants, design areas) |  | 62d | 2023-06-07 A | 2023-08-31 A | 480FS-10d | 100% |  | 2023-06-07 | 2023-08-31 | 62d | 2023-06-07 | 2023-08-01 |  |  | SI Design |  | DBT |  | 5.2 | Paul Pettitt | Design, Build & Test (PIT) | Complete | COMPLETE |  |  |  |  |
| 482 | 1.3.7.3.3.6 | SI endorsement of participants’ design – assurance reports |  | 43d | 2023-08-02 A | 2023-09-29 A | 481FS-22d | 100% |  | 2023-08-02 | 2023-09-29 | 43d | 2023-08-02 | 2023-08-15 |  |  | SI Design |  | DBT |  | 5.2 | Paul Pettitt | Design, Build & Test (PIT) | Complete | COMPLETE |  |  |  |  |
| 483 | 1.3.7.3.3.7 | Post-assurance review of recommendations take-up by assured participants |  | 44d | 2023-08-29 A | 2023-10-27 A | 482SS+19d | 100% |  | 2023-08-29 | 2023-10-27 | 20d | 2023-08-16 | 2023-10-27 |  |  | SI Design |  | DBT |  | 5.2 | Paul Pettitt | Design, Build & Test (PIT) | Complete | COMPLETE |  |  |  |  |
| 484 | 1.3.7.3.3.8 | Phase 1 - SIT Volunteers (Core Providers) complete | milestone | 0d | 2023-10-27 A | 2023-10-27 A | 483 | 100% |  | 2023-10-27 | 2023-10-27 | 0d | 2023-10-27 | 2023-10-27 |  |  | SI Design |  | DBT |  | 5.11 | Paul Pettitt | Design, Build & Test (PIT) | Complete | COMPLETE | T2-DB-0100 | DAG | T2 | MHHS-ART002 |

Notes:
- 462: 15/9 - query with John Wiggins where this sits

| ID | WBS | Task | Type | Duration | Start | Finish | Predecessors | Complete | Remaining | Baseline start | Baseline finish | Baseline duration | Baseline 1 start | Baseline 1 finish | Total slack | Constraint | Baseline cost | Responsible | Involved | Text9 | Update Version | MHHS Resource Name | MHHS Programme Phase | Sched Status | RAG | Artefact ID | Milestone ID | Text29 | Tier | Task Status | Text3 |
| --- | --- | --- | --- | --- | --- | --- | --- | --- | --- | --- | --- | --- | --- | --- | --- | --- | --- | --- | --- | --- | --- | --- | --- | --- | --- | --- | --- | --- | --- | --- | --- |
| 485 | 1.3.7.3.4 | **Phase 2 - SIT all other participants** |  | 143d | 2023-05-08 A | 2023-11-22 A |  | 100% |  | 2023-05-08 | 2023-11-22 | 143d | 2023-05-08 | 2023-11-22 |  |  |  | N/A | N/A | DBT | 5.0 | N/A | Design, Build & Test (PIT) |  |  |  |  |  |  |  |  |
| 486 | 1.3.7.3.4.1 | Send on-line questionnaire to core capability providers and current SIT volunteers (from Round 3 consultation) |  | 1d | 2023-05-08 A | 2023-05-08 A |  | 100% |  | 2023-05-08 | 2023-05-08 | 1d | 2023-05-08 | 2023-05-08 |  | must start on 2023-05-08 |  | SI Design | PP | DBT | 5.0 | Paul Pettitt | Design, Build & Test (PIT) | Complete | COMPLETE |  |  |  |  |  |  |
| 487 | 1.3.7.3.4.2 | Participants Provide Responses to questionnaires |  | 15d | 2023-05-09 A | 2023-05-29 A | 486 | 100% |  | 2023-05-09 | 2023-05-29 | 15d | 2023-05-09 | 2023-05-29 |  |  |  | PP |  | DBT | 5.0 | Paul Pettitt | Design, Build & Test (PIT) | Complete | COMPLETE |  |  |  |  |  |  |
| 488 | 1.3.7.3.4.3 | Assess on-line responses and provided evidence |  | 5d | 2023-05-30 A | 2023-06-05 A | 487 | 100% |  | 2023-05-30 | 2023-06-05 | 5d | 2023-05-30 | 2023-06-05 |  |  |  | SI Design |  | DBT | 5.0 | Paul Pettitt | Design, Build & Test (PIT) | Complete | COMPLETE |  |  |  |  |  |  |
| 489 | 1.3.7.3.4.4 | Bi-lateral meeting with each responder, to walk and navigate through provided materials |  | 84d | 2023-06-06 A | 2023-09-29 A | 488 | 100% |  | 2023-06-06 | 2023-09-29 | 84d | 2023-06-06 | 2023-07-18 |  |  |  | SI Design | PP | DBT | 5.2 | Paul Pettitt | Design, Build & Test (PIT) | Complete | COMPLETE |  |  |  |  |  |  |
| 490 | 1.3.7.3.4.5 | Plan for, create and execute deep dive assurance interviews based on agreed priorities (participants, design areas) |  | 69d | 2023-06-27 A | 2023-09-29 A | 489SS+15d | 100% |  | 2023-06-27 | 2023-09-29 | 69d | 2023-07-05 | 2023-08-29 |  |  |  | SI Design |  | DBT | 5.2 | Paul Pettitt | Design, Build & Test (PIT) | Complete | COMPLETE |  |  |  |  |  |  |
| 491 | 1.3.7.3.4.6 | SI endorsement of participants’ design – assurance reports |  | 54d | 2023-07-18 A | 2023-09-29 A | 490SS+15d | 100% |  | 2023-07-18 | 2023-09-29 | 54d | 2023-08-30 | 2023-09-12 |  |  |  | SI Design |  | DBT | 5.2 | Paul Pettitt | Design, Build & Test (PIT) | Complete | COMPLETE |  |  |  |  |  |  |
| 492 | 1.3.7.3.4.7 | Post-assurance review of recommendations take-up by assured participants |  | 73d | 2023-08-14 A | 2023-11-22 A | 491SS+19d | 100% |  | 2023-08-14 | 2023-11-22 | 38d | 2023-09-13 | 2023-11-22 |  |  |  | SI Design |  | DBT | 5.2 | Paul Pettitt | Design, Build & Test (PIT) | Complete | COMPLETE |  |  |  |  |  |  |
| 493 | 1.3.7.3.4.8 | SIT PPs design assurance (excl Migration/Reverse Migration) complete | milestone | 0d | 2023-11-22 A | 2023-11-22 A | 492 | 100% |  | 2023-11-22 | 2023-11-22 | 0d | 2023-11-22 | 2023-11-22 |  |  |  | SI Design |  | DBT | 5.11 | Paul Pettitt | Design, Build & Test (PIT) | Complete | COMPLETE | MHHS-ART002 | T2-DB-0200 | DAG | T2 |  |  |
| 494 | 1.3.7.3.5 | **Non-SIT PPs design assurance** |  | 445d | 2023-11-23 A | 2025-08-06 |  | 53% | 207d | 2023-11-23 | 2025-08-06 | 445d | 2023-11-23 | 2025-08-06 | 621d |  |  | N/A | N/A | DBT | 5.0 | N/A | Design, Build & Test (PIT) |  |  |  |  |  |  |  |  |
| 495 | 1.3.7.3.5.1 | Non-SIT PPs design assurance (risk-based sample) |  | 445d | 2023-11-23 A | 2025-08-06 | 493 | 53% | 207d | 2023-11-23 | 2025-08-06 | 445d | 2023-11-23 | 2025-08-06 | 621d |  |  | SI Design | PPC | DBT | 5.0 | Paul Pettitt | Design, Build & Test (PIT) | Green | GREEN |  |  |  |  |  |  |
| 496 | 1.3.7.4 | **Test Assurance** |  | 629d | 2023-02-01 A | 2025-06-30 |  | 71% | 180d | 2023-02-01 | 2025-06-30 | 696d | 2022-10-31 | 2025-06-30 | 648d |  |  | N/A | N/A | DBT | 5.0 | N/A | Design, Build & Test (PIT) |  |  |  |  |  |  | M9 |  |
| 497 | 1.3.7.4.1 | Non-SIT PPs test assurance |  | 629d | 2023-02-01 A | 2025-06-30 |  | 71% | 180d | 2023-02-01 | 2025-06-30 | 629d | 2023-02-01 | 2025-06-30 | 648d |  |  | Code Bodies | PP,PPC,SI Test | DBT | 5.0 | Roger Robar | Design, Build & Test (PIT) | Green | GREEN |  |  |  |  |  |  |
| 498 | 1.3.7.5 | **Pre-Qualification Guidance (PIT Guidance)** |  | 67d | 2022-10-31 A | 2023-01-31 A |  | 100% |  | 2022-10-31 | 2023-01-31 | 67d | 2022-10-31 | 2023-01-31 |  |  |  | N/A | N/A | DBT | 5.0 | N/A | Design, Build & Test (PIT) |  |  |  |  |  |  |  |  |
| 499 | 1.3.7.5.1 | Develop document (incl. collaboration with code bodies, as required) |  | 56d | 2022-10-31 A | 2023-01-16 A |  | 100% |  | 2022-10-31 | 2023-01-16 | 56d | 2022-10-31 | 2023-01-16 |  |  |  | SI Test | Code Bodies | DBT | 5.0 |  | Design, Build & Test (PIT) | Complete | COMPLETE |  |  |  |  |  |  |
| 500 | 1.3.7.5.2 | Review, update and agree Pre-Qualification Guidance internally |  | 11d | 2023-01-17 A | 2023-01-31 A | 499 | 100% |  | 2023-01-17 | 2023-01-31 | 11d | 2023-01-17 | 2023-01-31 |  |  |  | SRO Function | IPA,SI Test | DBT | 5.0 |  | Design, Build & Test (PIT) | Complete | COMPLETE |  |  |  |  |  |  |
| 501 | 1.3.7.6 | **External Programme Dependency Management** |  | 0d | 2022-11-03 A | 2022-11-03 A |  | 100% |  | 2022-11-03 | 2022-11-03 | 0d | 2022-11-03 | 2022-11-03 |  |  |  | N/A | N/A | DBT | 5.0 | N/A | Design, Build & Test (PIT) |  |  |  |  |  |  |  |  |
| 502 | 1.3.7.6.1 | **SLC47** |  | 0d | 2022-11-03 A | 2022-11-03 A |  | 100% |  | 2022-11-03 | 2022-11-03 | 0d | 2022-11-03 | 2022-11-03 |  |  |  | N/A | N/A | DBT | 5.0 | N/A | Design, Build & Test (PIT) |  |  |  |  |  |  |  |  |
| 503 | 1.3.7.6.1.1 | SLC47 implementation date | milestone | 0d | 2022-11-03 A | 2022-11-03 A |  | 100% |  | 2022-11-03 | 2022-11-03 | 0d | 2022-11-03 | 2022-11-03 |  | start no earlier than 2022-11-03 |  | Ofgem |  | DBT | 5.0 |  | Design, Build & Test (PIT) | Complete | COMPLETE |  |  |  |  |  |  |
| 504 | 1.4 | **SYSTEMS INTEGRATION TESTING (SIT)** |  | 910d? | 2022-10-31 A | 2026-04-24 |  | 62% | 349.89d? | 2022-10-31 | 2026-04-24 | 841d | 2022-10-31 | 2026-01-19 |  |  | -0 | N/A | N/A | SIT |  | N/A | Systems Integration Testing (SIT) |  |  |  |  |  |  |  | 1 Aug 2023 - 30 Sep 2024 |
| 505 | 1.4.1 | **SIT Preparation** |  | 665d? | 2022-10-31 A | 2025-05-16 |  | 81% | 128.47d? | 2022-10-31 | 2025-05-16 | 611d | 2022-10-31 | 2025-03-10 | 679d |  | -0 | N/A | N/A | SIT | 5.0 | N/A | Systems Integration Testing (SIT) |  |  |  |  |  |  |  |  |
| 506 | 1.4.1.1 | **Test Artefact Development** |  | 472d | 2022-10-31 A | 2024-08-21 |  | 99% | 2.69d | 2022-10-31 | 2024-08-21 | 472d | 2022-10-31 | 2023-09-01 | 872d |  | -0 | N/A | N/A | SIT | 5.0 | N/A | Systems Integration Testing (SIT) |  |  |  |  |  |  | M9 |  |
| 507 | 1.4.1.1.1 | **Environment Approach & Plan** |  | 460d | 2022-11-16 A | 2024-08-21 A |  | 100% |  | 2022-11-16 | 2024-08-21 | 460d | 2022-11-16 | 2023-06-30 |  |  | -0 | N/A | N/A | SIT | 5.0 | N/A | Systems Integration Testing (SIT) |  |  |  |  |  |  |  |  |
| 508 | 1.4.1.1.1.1 | Environment Approach & Plan approved | milestone | 0d | 2022-11-16 A | 2022-11-16 A |  | 100% |  | 2022-11-16 | 2022-11-16 | 0d | 2022-11-16 | 2022-11-16 |  | start no earlier than 2022-11-16 |  | SI Test | PP | SIT | 5.0 | Simon Berry | Systems Integration Testing (SIT) | Complete | COMPLETE | MHHS-ART139 | T3-TE-0010 | SITAG | T3 |  |  |
| 509 | 1.4.1.1.1.2 | Environment Approach & Plan - Work Off |  | 157d | 2022-11-17 A | 2023-06-23 A | 508FS+1d | 100% |  | 2022-11-17 | 2023-06-23 | 157d | 2022-11-17 | 2023-06-23 |  |  |  | SI Test | PP | SIT | 5.0 | Simon Berry | Systems Integration Testing (SIT) | Complete | COMPLETE |  |  |  |  |  |  |
| 510 | 1.4.1.1.1.3 | Environment Approach & Plan - Work Off Approved | milestone | 0d | 2023-08-16 A | 2023-08-16 A | 509FS+5d | 100% |  | 2023-08-16 | 2023-08-16 | 0d | 2023-06-30 | 2023-06-30 |  | start no earlier than 2023-08-16 |  | SI Test | PP | SIT | 5.0 | Simon Berry | Systems Integration Testing (SIT) | Complete | COMPLETE | MHHS-ART139 | T3-TE-0068 | SITAG | T3 |  |  |
| 511 | 1.4.1.1.1.4 | Environment Approach and Plan - SIT Functional | milestone | 0d | 2023-11-20 A | 2023-11-20 A |  | 100% |  | 2023-11-20 | 2023-11-20 | 0d |  |  |  | start no earlier than 2023-11-20 |  | SI Test | PP | SIT | 5.12 | Simon Berry | Systems Integration Testing (SIT) | Complete | COMPLETE | MHHS-DEL 618 | T3-TE-0090 | SITAG | T3 |  |  |
| 512 | 1.4.1.1.1.5 | Define Approach to Simulator for Non-SIT LDSO | milestone | 0d | 2023-11-15 A | 2023-11-15 A |  | 100% |  | 2023-11-15 | 2023-11-15 | 0d |  |  |  | start no earlier than 2023-11-15 |  | SI Test | PP | SIT | 5.12 | Simon Berry |  | Complete | COMPLETE |  |  |  |  |  |  |
| 513 | 1.4.1.1.1.6 | Environment Approach and Plan - Non SIT LDSO Testing | milestone | 0d | 2024-04-17 A | 2024-04-17 A |  | 100% |  | 2024-04-17 | 2024-04-17 | 0d |  |  |  | start no earlier than 2024-04-17 |  | SI Test | PP | SIT | 5.22 | Simon Berry | Systems Integration Testing (SIT) | Complete | COMPLETE | MHHS-DEL 619 | T3-TE-0091 | SITAG/QAG | T3 |  |  |
| 514 | 1.4.1.1.1.7 | Environment Approach and Plan - S and A Testing | milestone | 0d | 2024-07-17 A | 2024-07-17 A |  | 100% |  | 2024-07-17 | 2024-07-17 | 0d |  |  |  | start no earlier than 2024-07-17 |  | SI Test | PP | SIT | 5.27 | Simon Berry | Systems Integration Testing (SIT) | Complete | COMPLETE | MHHS-DEL 619 | T3-TE-0120 | SITAG/QAG | T3 |  |  |
| 515 | 1.4.1.1.1.8 | Environment Approach and Plan - SIT Non Functional | milestone | 0d | 2024-06-19 A | 2024-06-19 A |  | 100% |  | 2024-06-19 | 2024-06-19 | 0d |  |  |  | start no earlier than 2024-06-19 |  | SI Test | PP | SIT | 5.27 | Simon Berry | Systems Integration Testing (SIT) | Complete | COMPLETE | MHHS-DEL 620 | T3-TE-0092 | SITAG | T3 |  |  |
| 516 | 1.4.1.1.1.9 | Environment Approach and Plan - Sandbox | milestone | 0d | 2024-08-21 A | 2024-08-21 A |  | 100% |  | 2024-08-21 | 2024-08-21 | 0d |  |  |  | start no earlier than 2024-08-21 |  | SI Test | PP | SIT | 5.27 | Simon Berry | Systems Integration Testing (SIT) | Complete | COMPLETE | MHHS-DEL 621 | T3-TE-0093 | SITAG/QAG | T3 |  |  |

Notes:
- 497: 15/9 - keep in plan until qualification reviewed
- 505: Action: 11/3: Ask Simon B for the link (line 1312) dip onboarding to non sit ldso
- 507: Action: 16/8 - add to milestone register. Build out detail further
- 508: Action: 25/7 - Simon to provide update
- 509: Action: 25/7 - Simon to provide update
- 510: Action: 25/7 - Simon to provide update
- 511: Action: 16/8 - add to milestone register. Build out detail further
- 513: Action: 16/8 - add to milestone register. Build out detail further
- 514: Action: 16/8 - add to milestone register. Build out detail further
- 515: Action: 16/8 - add to milestone register. Build out detail further
- 516: Action: 16/8 - add to milestone register. Build out detail further

| ID | WBS | Task | Type | Duration | Start | Finish | Predecessors | Complete | Remaining | Baseline start | Baseline finish | Baseline duration | Baseline 1 start | Baseline 1 finish | Total slack | Constraint | Baseline cost | Responsible | Involved | Text9 | Update Version | MHHS Resource Name | MHHS Programme Phase | Sched Status | RAG | Task Status | Milestone ID | Text29 | Tier |
| --- | --- | --- | --- | --- | --- | --- | --- | --- | --- | --- | --- | --- | --- | --- | --- | --- | --- | --- | --- | --- | --- | --- | --- | --- | --- | --- | --- | --- | --- |
| 517 | 1.4.1.1.2 | **Overarching Test Scope (for all stages)** |  | 65d | 2022-10-31 A | 2023-01-27 A |  | 100% |  | 2022-10-31 | 2023-01-27 | 175d | 2022-10-31 | 2023-06-30 |  |  |  | N/A | N/A | SIT | 5.0 | N/A | Systems Integration Testing (SIT) |  |  |  |  |  |  |
| 518 | 1.4.1.1.2.1 | **Overarching Test Scope (excl. Migration/Reverse Migration, NFT and Ops components)** |  | 65d | 2022-10-31 A | 2023-01-27 A |  | 100% |  | 2022-10-31 | 2023-01-27 | 65d | 2022-10-31 | 2023-01-27 |  |  |  | N/A | N/A | SIT | 5.0 | N/A | Systems Integration Testing (SIT) |  |  |  |  |  |  |
| 519 | 1.4.1.1.2.1.1 | Develop document (excl Migration/Reverse Migration, NFT and Ops components) |  | 55d | 2022-10-31 A | 2023-01-13 A | 47 | 100% |  | 2022-10-31 | 2023-01-13 | 55d | 2022-10-31 | 2023-01-13 |  |  |  | SI Test |  | SIT | 5.0 |  | Systems Integration Testing (SIT) | Complete | COMPLETE |  |  |  |  |
| 520 | 1.4.1.1.2.1.2 | Review, update & agree document (excl Migration/Reverse Migration, NFT and Ops components) |  | 10d | 2023-01-16 A | 2023-01-27 A | 519 | 100% |  | 2023-01-16 | 2023-01-27 | 10d | 2023-01-16 | 2023-01-27 |  |  |  | SI Test | IPA,Code Bodies,PP | SIT | 5.0 |  | Systems Integration Testing (SIT) | Complete | COMPLETE |  |  |  |  |
| 521 | 1.4.1.1.3 | **Configuration and Release Management Approach & Plan** |  | 164d | 2022-11-01 A | 2023-06-16 A |  | 100% |  | 2022-11-01 | 2023-06-16 | 164d | 2022-11-01 | 2023-04-28 |  |  |  | N/A | N/A | SIT | 5.0 | N/A | Systems Integration Testing (SIT) |  |  | M9 |  |  |  |
| 522 | 1.4.1.1.3.1 | Develop document |  | 69d | 2022-11-01 A | 2023-06-16 A |  | 100% |  | 2022-11-01 | 2023-06-16 | 69d | 2022-11-01 | 2023-01-31 |  | start no earlier than 2022-11-01 |  | SI Test |  | SIT | 5.0 | Simon Berry | Systems Integration Testing (SIT) | Complete | COMPLETE |  |  |  |  |
| 523 | 1.4.1.1.3.2 | Review, update and agree Configuration and Release Management Approach & Plan internally |  | 63d | 2023-02-01 A | 2023-04-28 A | 522 | 100% |  | 2023-02-01 | 2023-04-28 | 63d | 2023-02-01 | 2023-04-28 |  |  |  | SRO Function | IPA,SI Test | SIT | 5.0 | Simon Berry | Systems Integration Testing (SIT) | Complete | COMPLETE |  |  |  |  |
| 524 | 1.4.1.1.4 | **Test Data Overarching Approach & Plan** |  | 179d | 2022-11-14 A | 2023-07-20 A |  | 100% |  | 2022-11-14 | 2023-07-20 | 179d | 2022-11-14 | 2023-05-18 |  |  |  | N/A | N/A | SIT | 5.0 | N/A | Systems Integration Testing (SIT) |  |  | M9 |  |  |  |
| 525 | 1.4.1.1.4.1 | Develop document |  | 20d | 2022-11-14 A | 2022-12-09 A |  | 100% |  | 2022-11-14 | 2022-12-09 | 20d | 2022-11-14 | 2022-12-09 |  | start no earlier than 2022-11-14 |  | SI Test | PP | SIT | 5.0 | Cesar Lopes | Systems Integration Testing (SIT) | Complete | COMPLETE |  |  |  |  |
| 526 | 1.4.1.1.4.2 | Document review and update |  | 155d | 2022-12-12 A | 2023-07-14 A | 525 | 100% |  | 2022-12-12 | 2023-07-14 | 155d | 2022-12-12 | 2023-05-17 |  |  |  | PP | SI Test,IPA | SIT | 5.0 | Cesar Lopes | Systems Integration Testing (SIT) | Complete | COMPLETE |  |  |  |  |
| 527 | 1.4.1.1.4.3 | Test Data Overarching Approach & Plan approved by TMAG | milestone | 0d | 2023-07-19 A | 2023-07-19 A | 526FS+3d | 100% |  | 2023-07-19 | 2023-07-19 | 0d | 2023-05-17 | 2023-05-17 |  |  |  | SRO Test | PP,IPA,Code Bodies | SIT | 5.0 | Cesar Lopes | Systems Integration Testing (SIT) | Complete | COMPLETE |  | T3-TE-0072 | SITAG | T3 |
| 528 | 1.4.1.1.4.4 | Document publication final version |  | 1d | 2023-07-20 A | 2023-07-20 A | 527 | 100% |  | 2023-07-20 | 2023-07-20 | 1d | 2023-05-18 | 2023-05-18 |  |  |  | SI Test |  | SIT | 5.0 | Cesar Lopes | Systems Integration Testing (SIT) | Complete | COMPLETE |  |  |  |  |
| 529 | 1.4.1.1.5 | **Interface Code of Connection (dates subject to DIP Service Provider's plan)** |  | 48d | 2023-03-01 A | 2023-05-05 A |  | 100% |  | 2023-03-01 | 2023-05-05 | 48d | 2023-03-01 | 2023-05-05 |  |  |  | N/A | N/A | SIT | 5.0 | N/A | Systems Integration Testing (SIT) |  |  |  |  |  |  |
| 530 | 1.4.1.1.5.1 | Develop Interface Code of Connection with DIP Service Provider |  | 43d | 2023-03-01 A | 2023-04-28 A |  | 100% |  | 2023-03-01 | 2023-04-28 | 43d | 2023-03-01 | 2023-04-28 |  | must start on 2023-03-01 |  | DIP Provider | SI Test | SIT | 5.0 |  | Systems Integration Testing (SIT) | Complete | COMPLETE |  |  |  |  |
| 531 | 1.4.1.1.5.2 | Interface Code of Connection approved at SDWG | milestone | 0d | 2023-05-05 A | 2023-05-05 A | 530FS+5d | 100% |  | 2023-05-05 | 2023-05-05 | 0d | 2023-05-05 | 2023-05-05 |  |  |  | SI Test | PP | SIT | 5.0 |  | Systems Integration Testing (SIT) | Complete | COMPLETE |  |  |  |  |
| 532 | 1.4.1.1.6 | **Test Traceability** |  | 165d | 2023-06-01 A | 2024-01-17 |  | 98% | 2.71d | 2023-06-01 | 2024-01-17 | 165d | 2023-06-01 | 2023-09-01 | 1026d |  | -0 | N/A | N/A | SIT | 5.0 | N/A | Systems Integration Testing (SIT) |  |  |  |  |  |  |
| 533 | 1.4.1.1.6.1 | RTM containing Method Statement Implied Requirements into Azure DevOps |  | 22d | 2023-06-01 A | 2023-06-30 A |  | 100% |  | 2023-06-01 | 2023-06-30 | 22d | 2023-06-01 | 2023-06-30 |  | must start on 2023-06-01 |  | SI Test |  | SIT | 5.0 |  | Systems Integration Testing (SIT) | Complete | COMPLETE |  |  |  |  |
| 534 | 1.4.1.1.6.2 | RTM Containing Interface Catalogue Implied Requirements |  | 27d | 2023-06-01 A | 2023-07-07 A |  | 100% |  | 2023-06-01 | 2023-07-07 | 27d | 2023-06-01 | 2023-07-07 |  | must start on 2023-06-01 |  | SI Test |  | SIT | 5.0 |  | Systems Integration Testing (SIT) | Complete | COMPLETE |  |  |  |  |
| 535 | 1.4.1.1.6.3 | SIT CIT Full Traceability & Coverage complete |  | 118d | 2023-07-10 A | 2023-12-20 A | 534, 533 | 100% |  | 2023-07-10 | 2023-12-20 | 110d | 2023-07-10 | 2023-07-28 |  |  |  | SI Test |  | SIT | 5.0 |  | Systems Integration Testing (SIT) | Complete | COMPLETE |  |  |  |  |
| 536 | 1.4.1.1.6.4 | SIT Functional Full Traceability & Coverage complete |  | 138d | 2023-07-10 A | 2024-01-17 | 534, 533 | 96% | 5d | 2023-07-10 | 2024-01-17 | 138d | 2023-07-10 | 2023-09-01 | 1026d |  |  | SI Test |  | SIT | 5.0 | Roger Robar | Systems Integration Testing (SIT) | Overdue | RED |  |  |  |  |
| 537 | 1.4.1.2 | **Test Tool Development** |  | 256d? | 2022-10-31 A | 2023-10-23 A |  | 100% |  | 2022-10-31 | 2023-10-23 | 175d | 2022-10-31 | 2023-06-30 |  |  |  | N/A | N/A | SIT | 5.0 | N/A | Systems Integration Testing (SIT) |  |  |  |  |  |  |
| 538 | 1.4.1.2.1 | **Test Management Tool** |  | 256d | 2022-10-31 A | 2023-10-23 A |  | 100% |  | 2022-10-31 | 2023-10-23 | 175d | 2022-10-31 | 2023-06-30 |  |  |  | N/A | N/A | SIT | 5.0 | N/A | Systems Integration Testing (SIT) |  |  |  |  |  |  |
| 539 | 1.4.1.2.1.1 | **Test Management Tool Implementation** |  | 256d | 2022-10-31 A | 2023-10-23 A |  | 100% |  | 2022-10-31 | 2023-10-23 | 175d | 2022-10-31 | 2023-06-30 |  |  |  | N/A | N/A | SIT | 5.0 | N/A | Systems Integration Testing (SIT) |  |  |  |  |  |  |
| 540 | 1.4.1.2.1.1.1 | Requirements identification |  | 40d | 2022-10-31 A | 2022-12-23 A |  | 100% |  | 2022-10-31 | 2022-12-23 | 40d | 2022-10-31 | 2022-12-23 |  |  |  | SI DevOps | SI Test | SIT | 5.0 | Simon Berry | Systems Integration Testing (SIT) | Complete | COMPLETE |  |  |  |  |
| 541 | 1.4.1.2.1.1.2 | Development |  | 125d | 2023-01-02 A | 2023-06-23 A | 540FS+5d | 100% |  | 2023-01-02 | 2023-06-23 | 125d | 2023-01-02 | 2023-06-23 |  |  |  | SI DevOps | SI Test | SIT | 5.0 | Simon Berry | Systems Integration Testing (SIT) | Complete | COMPLETE |  |  |  |  |
| 542 | 1.4.1.2.1.1.3 | Testing |  | 125d | 2023-01-02 A | 2023-06-23 A | 541FF | 100% |  | 2023-01-02 | 2023-06-23 | 125d | 2023-01-02 | 2023-06-23 |  |  |  | SI DevOps | SI Test | SIT | 5.0 | Simon Berry | Systems Integration Testing (SIT) | Complete | COMPLETE |  |  |  |  |
| 543 | 1.4.1.2.1.1.4 | Accept tool | milestone | 0d | 2023-06-23 A | 2023-06-23 A | 542FF | 100% |  | 2023-06-23 | 2023-06-23 | 0d | 2023-06-23 | 2023-06-23 |  |  |  | SI DevOps | SI Test | SIT | 5.0 | Simon Berry | Systems Integration Testing (SIT) | Complete | COMPLETE |  |  |  |  |
| 544 | 1.4.1.2.1.1.5 | Implementation |  | 1d | 2023-10-23 A | 2023-10-23 A | 543FS+85d | 100% |  | 2023-10-23 | 2023-10-23 | 1d | 2023-06-30 | 2023-06-30 |  |  |  | SI DevOps | PPC | SIT | 5.0 | Simon Berry | Systems Integration Testing (SIT) | Complete | COMPLETE |  |  |  |  |

Notes:
- 521: Action: 1280 DIP available for Onboarding (need to add a link - non sit ldso)

| ID | WBS | Task | Duration | Start | Finish | Predecessors | Complete | Baseline start | Baseline finish | Baseline duration | Baseline 1 start | Baseline 1 finish | Constraint | Responsible | Involved | Text9 | Update Version | MHHS Resource Name | MHHS Programme Phase | Sched Status | RAG | Task Status |
| --- | --- | --- | --- | --- | --- | --- | --- | --- | --- | --- | --- | --- | --- | --- | --- | --- | --- | --- | --- | --- | --- | --- |
| 545 | 1.4.1.2.1.2 | **Test Management Tool User Guide** | 115d | 2023-01-02 A | 2023-06-09 A |  | 100% | 2023-01-02 | 2023-06-09 | 115d | 2023-01-02 | 2023-06-09 |  | N/A | N/A | SIT | 5.0 | N/A | Systems Integration Testing (SIT) |  |  |  |
| 546 | 1.4.1.2.1.2.1 | Develop document | 100d | 2023-01-02 A | 2023-05-19 A | 541SS, 542SS | 100% | 2023-01-02 | 2023-05-19 | 100d | 2023-01-02 | 2023-05-19 | start no earlier than 2023-01-02 | SI DevOps |  | SIT | 5.0 |  | Systems Integration Testing (SIT) | Complete | COMPLETE |  |
| 547 | 1.4.1.2.1.2.2 | Review, update and agree Test Management Tool User Guide internally | 15d | 2023-05-22 A | 2023-06-09 A | 546 | 100% | 2023-05-22 | 2023-06-09 | 15d | 2023-05-22 | 2023-06-09 |  | SRO Function | SI DevOps,SI Test,IPA,PPC | SIT | 5.0 |  | Systems Integration Testing (SIT) | Complete | COMPLETE |  |
| 548 | 1.4.1.2.1.3 | **Test Management Tool Configuration Guide** | 60d | 2023-01-02 A | 2023-03-24 A |  | 100% | 2023-01-02 | 2023-03-24 | 60d | 2023-01-02 | 2023-03-24 |  | N/A | N/A | SIT | 5.0 | N/A | Systems Integration Testing (SIT) |  |  |  |
| 549 | 1.4.1.2.1.3.1 | Develop document | 45d | 2023-01-02 A | 2023-03-03 A | 540 | 100% | 2023-01-02 | 2023-03-03 | 45d | 2023-01-02 | 2023-03-03 | start no earlier than 2023-01-02 | SI DevOps | SI Test,IPA | SIT | 5.0 |  | Systems Integration Testing (SIT) | Complete | COMPLETE |  |
| 550 | 1.4.1.2.1.3.2 | Review, update and agree Test Management Tool Configuration Guide internally | 15d | 2023-03-06 A | 2023-03-24 A | 549 | 100% | 2023-03-06 | 2023-03-24 | 15d | 2023-03-06 | 2023-03-24 |  | SRO Function | SI DevOps,SI Test,IPA | SIT | 5.0 |  | Systems Integration Testing (SIT) | Complete | COMPLETE |  |
| 551 | 1.4.1.2.2 | **Secure Volunteer SIT Participants** | 163d? | 2023-01-31 A | 2023-09-14 A |  | 100% | 2023-01-31 | 2023-09-14 | 0d |  |  |  |  |  | SIT | 6.0 |  |  | Overdue Start |  | -680.67 |
| 552 | 1.4.1.2.2.1 | PPs decide whether to volunteer to participate in SIT and inform Programme of decision via Round 3 Replan consultation | 1d? | 2023-01-31 A | 2023-01-31 A |  | 100% | 2023-01-31 | 2023-01-31 | 0d |  |  | finish no earlier than 2023-01-31 | SI Test |  | SIT | 6.0 |  |  | Complete | COMPLETE |  |
| 553 | 1.4.1.2.2.2 | Assurance of SIT volunteers' plans (submitted via Round 3 Replan Consultation) | 1d? | 2023-02-14 A | 2023-02-14 A |  | 100% | 2023-02-14 | 2023-02-14 | 0d |  |  | finish no earlier than 2023-02-14 | SI Test |  | SIT | 6.0 |  |  | Complete | COMPLETE |  |
| 554 | 1.4.1.2.2.3 | SIT Participant Volunteers Identified | 1d? | 2023-02-14 A | 2023-02-14 A |  | 100% | 2023-02-14 | 2023-02-14 | 0d |  |  | start no earlier than 2023-02-14 | SI Test |  | SIT | 6.0 |  |  | Complete | COMPLETE |  |
| 555 | 1.4.1.2.2.4 | Engagement with SIT volunteers | 1d? | 2023-05-23 A | 2023-05-23 A |  | 100% | 2023-05-23 | 2023-05-23 | 0d |  |  | finish no earlier than 2023-05-23 | SI Test |  | SIT | 6.0 |  |  | Complete | COMPLETE |  |
| 556 | 1.4.1.2.2.5 | SIT Participants Agreed | 1d? | 2023-05-23 A | 2023-05-23 A |  | 100% | 2023-05-23 | 2023-05-23 | 0d |  |  | start no earlier than 2023-05-23 | SI Test |  | SIT | 6.0 |  |  | Complete | COMPLETE |  |
| 557 | 1.4.1.2.2.6 | **Data Protection Impact Assessment (DPIA)** | 11d? | 2023-06-30 A | 2023-07-14 A |  | 100% | 2023-06-30 | 2023-07-14 | 0d |  |  |  | SI Test |  | SIT | 6.0 |  |  | Overdue Start |  | -680.67 |
| 558 | 1.4.1.2.2.6.1 | Conduct DPIA on Overall Test Data Approach | 1d? | 2023-06-30 A | 2023-06-30 A |  | 100% | 2023-06-30 | 2023-06-30 | 0d |  |  | finish no earlier than 2023-06-30 | SI Test |  | SIT | 6.0 |  |  | Complete | COMPLETE |  |
| 559 | 1.4.1.2.2.6.2 | Revise Overarching Test Data Approach& plan for DPIA (if required), including engagement with DWG | 1d? | 2023-07-13 A | 2023-07-13 A |  | 100% | 2023-07-13 | 2023-07-13 | 0d |  |  | finish no earlier than 2023-07-13 | SI Test |  | SIT | 6.0 |  |  | Complete | COMPLETE |  |
| 560 | 1.4.1.2.2.6.3 | Review (internal), update and approve revised Overarching Test Data Approach& Plan (if required) | 1d? | 2023-07-14 A | 2023-07-14 A |  | 100% | 2023-07-14 | 2023-07-14 | 0d |  |  | start no earlier than 2023-07-14 | SI Test |  | SIT | 6.0 |  |  | Complete | COMPLETE |  |
| 561 | 1.4.1.2.2.7 | **Data Sharing Agreements** | 30d? | 2023-08-04 A | 2023-09-14 A |  | 100% | 2023-08-04 | 2023-09-14 | 0d |  |  |  | SI Test |  | SIT | 6.0 |  |  | Overdue Start | COMPLETE | -680.67 |
| 562 | 1.4.1.2.2.7.1 | Produce Data Sharing Agreement for Industry Review | 1d? | 2023-08-04 A | 2023-08-04 A |  | 100% | 2023-08-04 | 2023-08-04 | 0d |  |  | finish no earlier than 2023-08-04 | SI Test |  | SIT | 6.0 |  |  | Complete | COMPLETE |  |
| 563 | 1.4.1.2.2.7.2 | Manage Participant Queries and Contract Agreement Execution | 1d? | 2023-09-14 A | 2023-09-14 A |  | 100% | 2023-09-14 | 2023-09-14 | 0d |  |  | finish no earlier than 2023-09-14 | SI Test |  | SIT | 6.0 |  |  | Complete | COMPLETE |  |
| 564 | 1.4.1.2.2.7.3 | Data Sharing Agreements Complete | 1d? | 2023-09-14 A | 2023-09-14 A |  | 100% | 2023-09-14 | 2023-09-14 | 0d |  |  | start no earlier than 2023-09-14 | SI Test |  | SIT | 6.0 |  |  | Complete | COMPLETE |  |
| 565 | 1.4.1.2.2.8 | **Production Data Cut & Data Obfuscation** | 55d? | 2023-06-19 A | 2023-09-01 A |  | 100% | 2023-06-19 | 2023-09-01 | 0d |  |  |  |  |  | SIT | 6.0 |  |  | Overdue Start | COMPLETE | -680.67 |
| 566 | 1.4.1.2.2.8.1 | **SI Data Cut Preparation& Infrastructure** | 45d? | 2023-06-19 A | 2023-08-18 A |  | 100% | 2023-06-19 | 2023-08-18 | 0d |  |  |  |  |  | SIT | 6.0 |  |  | Overdue Start | COMPLETE | -680.67 |
| 567 | 1.4.1.2.2.8.1.1 | SI Data Cut Planning activities (incl. pre-cut and post-cut cleansing and population approach) | 1d? | 2023-06-19 A | 2023-06-19 A |  | 100% | 2023-06-19 | 2023-06-19 | 0d |  |  | finish no earlier than 2023-06-19 |  |  | SIT | 6.0 |  |  | Complete | COMPLETE |  |
| 568 | 1.4.1.2.2.8.1.2 | Set up SI database and transmission structure | 1d? | 2023-08-17 A | 2023-08-17 A |  | 100% | 2023-08-17 | 2023-08-17 | 0d |  |  | finish no earlier than 2023-08-17 |  |  | SIT | 6.0 |  |  | Complete | COMPLETE |  |
| 569 | 1.4.1.2.2.8.1.3 | Mechanism for transfer of data in place | 1d? | 2023-08-18 A | 2023-08-18 A |  | 100% | 2023-08-18 | 2023-08-18 | 0d |  |  | start no earlier than 2023-08-18 |  |  | SIT | 6.0 |  |  | Complete | COMPLETE |  |
| 570 | 1.4.1.2.2.8.1.4 | SI Data Cut Preparation& Infrastructure Complete | 1d? | 2023-08-18 A | 2023-08-18 A |  | 100% | 2023-08-18 | 2023-08-18 | 0d |  |  | start no earlier than 2023-08-18 |  |  | SIT | 6.0 |  |  | Complete | COMPLETE |  |

| ID | WBS | Task | Type | Duration | Start | Finish | Predecessors | Complete | Remaining | Baseline start | Baseline finish | Baseline duration | Baseline 1 start | Baseline 1 finish | Total slack | Constraint | Baseline cost | Text9 | Task Status | Update Version | Sched Status | RAG | Responsible | Involved | MHHS Resource Name | MHHS Programme Phase | Milestone ID | Text29 | Tier | Artefact ID |
| --- | --- | --- | --- | --- | --- | --- | --- | --- | --- | --- | --- | --- | --- | --- | --- | --- | --- | --- | --- | --- | --- | --- | --- | --- | --- | --- | --- | --- | --- | --- |
| 571 | 1.4.1.2.2.8.2 | **Production Data Cut** |  | 55d? | 2023-06-19 A | 2023-09-01 A |  | 100% |  | 2023-06-19 | 2023-09-01 | 0d |  |  |  |  |  | SIT | -680.67 | 6.0 | Overdue Start | COMPLETE |  |  |  |  |  |  |  |  |
| 572 | 1.4.1.2.2.8.2.1 | Notification of Production Data Cut issued to relevant participants |  | 1d? | 2023-06-19 A | 2023-06-19 A |  | 100% |  | 2023-06-19 | 2023-06-19 | 0d |  |  |  | start no earlier than 2023-06-19 |  | SIT |  | 6.0 | Complete | COMPLETE |  |  |  |  |  |  |  |  |
| 573 | 1.4.1.2.2.8.2.2 | Coordinate relevant participants taking data cut from production systems |  | 1d? | 2023-08-11 A | 2023-08-11 A |  | 100% |  | 2023-08-11 | 2023-08-11 | 0d |  |  |  | finish no earlier than 2023-08-11 |  | SIT |  | 6.0 | Complete | COMPLETE |  |  |  |  |  |  |  |  |
| 574 | 1.4.1.2.2.8.2.3 | Production data cut GONG decision |  | 1d? | 2023-08-16 A | 2023-08-16 A |  | 100% |  | 2023-08-16 | 2023-08-16 | 0d |  |  |  | start no earlier than 2023-08-16 |  | SIT |  | 6.0 | Complete | COMPLETE |  |  |  |  |  |  |  |  |
| 575 | 1.4.1.2.2.8.2.4 | Relevant participants take data cut from production systems (Saturday 19 August) |  | 1d? | 2023-08-21 A | 2023-08-21 A |  | 100% |  | 2023-08-21 | 2023-08-21 | 0d |  |  |  | start no earlier than 2023-08-21 |  | SIT |  | 6.0 | Complete | COMPLETE |  |  |  |  |  |  |  |  |
| 576 | 1.4.1.2.2.8.2.5 | EES transmit request data to SI |  | 1d? | 2023-08-25 A | 2023-08-25 A |  | 100% |  | 2023-08-25 | 2023-08-25 | 0d |  |  |  | finish no earlier than 2023-08-25 |  | SIT |  | 6.0 | Complete | COMPLETE |  |  |  |  |  |  |  |  |
| 577 | 1.4.1.2.2.8.2.6 | Check data alignment and integrity of data cut |  | 1d? | 2023-09-01 A | 2023-09-01 A |  | 100% |  | 2023-09-01 | 2023-09-01 | 0d |  |  |  | finish no earlier than 2023-09-01 |  | SIT |  | 6.0 | Complete | COMPLETE |  |  |  |  |  |  |  |  |
| 578 | 1.4.1.2.2.8.2.7 | Data cut from relevant participants' production systems completed (Saturday 19 August) |  | 1d? | 2023-08-21 A | 2023-08-21 A |  | 100% |  | 2023-08-21 | 2023-08-21 | 0d |  |  |  | start no earlier than 2023-08-21 |  | SIT |  | 6.0 | Complete | COMPLETE |  |  |  |  |  |  |  |  |
| 579 | 1.4.1.2.2.8.2.8 | Production Data Cut Complete |  | 1d? | 2023-08-21 A | 2023-08-21 A |  | 100% |  | 2023-08-21 | 2023-08-21 | 0d |  |  |  | start no earlier than 2023-08-21 |  | SIT |  | 6.0 | Complete | COMPLETE |  |  |  |  |  |  |  |  |
| 580 | 1.4.1.3 | **SIT Participation** |  | 147d | 2022-10-31 A | 2023-05-23 A |  | 100% |  | 2022-10-31 | 2023-05-23 | 147d | 2022-10-31 | 2023-05-23 |  |  |  | SIT |  | 5.0 |  |  | N/A | N/A | N/A | Systems Integration Testing (SIT) |  |  |  |  |
| 581 | 1.4.1.3.1 | PPs decide whether to volunteer to participate in SIT and inform Programme of decision via Round 3 Replan consultation |  | 67d | 2022-10-31 A | 2023-01-31 A | 34FF | 100% |  | 2022-10-31 | 2023-01-31 | 67d | 2022-10-31 | 2023-01-31 |  |  |  | SIT |  | 5.0 | Complete | COMPLETE | PP | SI Test,PMO |  | Systems Integration Testing (SIT) |  |  |  |  |
| 582 | 1.4.1.3.2 | Assurance of SIT volunteers' plans (submitted via Round 3 Replan Consultation) |  | 10d | 2023-02-01 A | 2023-02-14 A | 581, 34 | 100% |  | 2023-02-01 | 2023-02-14 | 10d | 2023-02-01 | 2023-02-14 |  |  |  | SIT |  | 5.0 | Complete | COMPLETE | SI Test | PP |  | Systems Integration Testing (SIT) |  |  |  |  |
| 583 | 1.4.1.3.3 | SIT Participant Volunteers Identified | milestone | 0d | 2023-02-14 A | 2023-02-14 A | 582FF | 100% |  | 2023-02-14 | 2023-02-14 | 0d | 2023-02-14 | 2023-02-14 |  |  |  | SIT |  | 5.0 | Complete | COMPLETE | SI Test | PP |  | Systems Integration Testing (SIT) | T2-TE-0100 | SITAG | T2 |  |
| 584 | 1.4.1.3.4 | Engagement with SIT volunteers |  | 147d | 2022-10-31 A | 2023-05-23 A |  | 100% |  | 2022-10-31 | 2023-05-23 | 147d | 2022-10-31 | 2023-05-23 |  |  |  | SIT |  | 5.0 | Complete | COMPLETE | SI Test | PP |  | Systems Integration Testing (SIT) |  |  |  |  |
| 585 | 1.4.1.3.5 | SIT Participants Agreed | milestone | 0d | 2023-05-23 A | 2023-05-23 A | 584, 619FS-74d | 100% |  | 2023-05-23 | 2023-05-23 | 0d | 2023-05-23 | 2023-05-23 |  |  |  | SIT |  | 5.0 | Complete | COMPLETE | SI Test | PP |  | Systems Integration Testing (SIT) | T2-TE-0150 | SITAG | T2 |  |
| 586 | 1.4.1.4 | **SIT Stage-Specific Preparation** |  | 665d? | 2022-10-31 A | 2025-05-16 |  | 76% | 157.16d? | 2022-10-31 | 2025-05-16 | 611d | 2022-10-31 | 2025-03-10 | 679d |  | -0 | SIT |  | 5.0 |  |  | N/A | N/A | N/A | Systems Integration Testing (SIT) |  |  |  |  |
| 587 | 1.4.1.4.1 | **SIT Component Integration Preparation** |  | 320d | 2022-10-31 A | 2024-01-19 A |  | 100% |  | 2022-10-31 | 2024-01-19 | 321d | 2022-10-31 | 2024-01-22 |  |  | -0 | SIT |  | 5.0 |  |  | N/A | N/A | N/A | Systems Integration Testing (SIT) |  |  |  |  |
| 588 | 1.4.1.4.1.1 | **Test Approach & Plan** |  | 188d | 2022-10-31 A | 2023-07-19 A |  | 100% |  | 2022-10-31 | 2023-07-19 | 188d | 2022-10-31 | 2023-07-19 |  |  |  | SIT |  | 5.0 |  |  | N/A | N/A | N/A | Systems Integration Testing (SIT) |  |  |  |  |
| 589 | 1.4.1.4.1.1.1 | Develop document with SITWG |  | 159d | 2022-10-31 A | 2023-06-08 A |  | 100% |  | 2022-10-31 | 2023-06-08 | 159d | 2022-10-31 | 2023-05-12 |  |  |  | SIT |  | 5.0 | Complete | COMPLETE | SI Test |  |  | Systems Integration Testing (SIT) |  |  |  |  |
| 590 | 1.4.1.4.1.1.2 | Industry consultation |  | 10d | 2023-06-09 A | 2023-06-22 A | 589 | 100% |  | 2023-06-09 | 2023-06-22 | 10d |  |  |  |  |  | SIT |  | 5.1 | Complete | COMPLETE | PP |  |  | Systems Integration Testing (SIT) |  |  |  |  |
| 591 | 1.4.1.4.1.1.3 | Artefact review (via TMAG) and updates |  | 19d | 2023-06-23 A | 2023-07-19 A | 590 | 100% |  | 2023-06-23 | 2023-07-19 | 19d | 2023-06-09 | 2023-07-06 |  | finish no earlier than 2023-07-06 |  | SIT |  | 5.0 | Complete | COMPLETE | SI Test | PP,IPA,Code Bodies |  | Systems Integration Testing (SIT) |  |  |  |  |
| 592 | 1.4.1.4.1.1.4 | SIT Component Integration Testing Test Approach & Plan approved | milestone | 0d | 2023-07-19 A | 2023-07-19 A | 591 | 100% |  | 2023-07-19 | 2023-07-19 | 0d | 2023-07-19 | 2023-07-19 |  | finish no earlier than 2023-07-19 |  | SIT |  | 5.0 | Complete | COMPLETE | SI Test | PP |  | Systems Integration Testing (SIT) | T3-TE-0012 | SITAG | T3 | MHHS-ART073 |
| 593 | 1.4.1.4.1.2 | **Test Data Approach & Plan** |  | 29d | 2023-06-09 A | 2023-07-19 A |  | 100% |  | 2023-06-09 | 2023-07-19 | 29d | 2023-06-09 | 2023-07-19 |  |  |  | SIT |  | 5.0 |  |  | N/A | N/A | N/A | Systems Integration Testing (SIT) |  |  |  |  |
| 594 | 1.4.1.4.1.2.1 | Industry consultation |  | 10d | 2023-06-09 A | 2023-06-22 A | 590SS | 100% |  | 2023-06-09 | 2023-06-22 | 10d |  |  |  |  |  | SIT |  | 5.1 | Complete | COMPLETE | PP |  | Cesar Lopes | Systems Integration Testing (SIT) |  |  |  |  |
| 595 | 1.4.1.4.1.2.2 | Artefact review (via TMAG) and updates |  | 19d | 2023-06-23 A | 2023-07-19 A | 594 | 100% |  | 2023-06-23 | 2023-07-19 | 19d | 2023-06-09 | 2023-07-06 |  |  |  | SIT |  | 5.0 | Complete | COMPLETE | SI Test | PP | Cesar Lopes | Systems Integration Testing (SIT) |  |  |  |  |
| 596 | 1.4.1.4.1.2.3 | SIT Component Integration Testing Test Data Approach & Plan approved | milestone | 0d | 2023-07-19 A | 2023-07-19 A | 595 | 100% |  | 2023-07-19 | 2023-07-19 | 0d | 2023-07-19 | 2023-07-19 |  |  |  | SIT |  | 5.0 | Complete | COMPLETE | SI Test | IPA | Cesar Lopes | Systems Integration Testing (SIT) |  |  |  |  |

| ID | WBS | Task | Type | Duration | Start | Finish | Predecessors | Complete | Baseline start | Baseline finish | Baseline duration | Baseline 1 start | Baseline 1 finish | Constraint | Baseline cost | Responsible | Involved | Text9 | Update Version | MHHS Resource Name | MHHS Programme Phase | Sched Status | RAG | Artefact ID | Milestone ID | Text29 | Tier | Task Status |
| --- | --- | --- | --- | --- | --- | --- | --- | --- | --- | --- | --- | --- | --- | --- | --- | --- | --- | --- | --- | --- | --- | --- | --- | --- | --- | --- | --- | --- |
| 597 | 1.4.1.4.1.3 | **Test scenarios** |  | 173d | 2023-01-02 A | 2023-08-30 A |  | 100% | 2023-01-02 | 2023-08-30 | 173d | 2023-01-02 | 2023-06-02 |  |  | N/A | N/A | SIT | 5.0 | N/A | Systems Integration Testing (SIT) |  |  |  |  |  |  |  |
| 598 | 1.4.1.4.1.3.1 | Development of test scenarios | milestone | 0d | 2023-01-02 A | 2023-04-28 A | 589SS+45d | 100% | 2023-01-02 | 2023-04-28 | 85d | 2023-01-02 | 2023-04-28 |  |  | SI Test | PP, Code Bodies | SIT | 5.0 |  | Systems Integration Testing (SIT) | Complete | COMPLETE |  |  |  |  |  |
| 599 | 1.4.1.4.1.3.2 | Review test scenarios with SIT Working Group |  | 11d | 2023-02-01 A | 2023-08-09 A | 598SS+22d | 100% | 2023-02-01 | 2023-08-09 | 136d | 2023-02-01 | 2023-05-26 |  |  | SI Test | PP, Code Bodies, IPA | SIT | 5.0 |  | Systems Integration Testing (SIT) | Complete | COMPLETE |  |  |  |  |  |
| 600 | 1.4.1.4.1.3.3 | SIT Component Integration Testing Test scenarios approved | milestone | 0d | 2023-08-30 A | 2023-08-30 A | 599FS+15d | 100% | 2023-08-30 | 2023-08-30 | 0d | 2023-06-02 | 2023-06-02 |  |  | SI Test | PP | SIT | 5.6 |  | Systems Integration Testing (SIT) | Complete | COMPLETE | MHHS-ART148 | T3-TE-0014 | SITAG | T3 |  |
| 601 | 1.4.1.4.1.4 | **Test cases** |  | 160d | 2023-05-01 A | 2023-12-08 A |  | 100% | 2023-05-01 | 2023-12-08 | 160d | 2023-05-01 | 2023-09-01 |  |  | N/A | N/A | SIT | 5.6 | N/A | Systems Integration Testing (SIT) |  |  |  |  |  |  |  |
| 602 | 1.4.1.4.1.4.1 | **SI Test cases** |  | 160d | 2023-05-01 A | 2023-12-08 A |  | 100% | 2023-05-01 | 2023-12-08 | 160d | 2023-05-01 | 2023-09-01 |  |  | N/A | N/A | SIT | 5.6 | N/A | Systems Integration Testing (SIT) |  |  |  |  |  |  |  |
| 603 | 1.4.1.4.1.4.1.1 | **Batch 1 (CIT Intervals 1 and 2)** |  | 110d | 2023-05-01 A | 2023-09-29 A |  | 100% | 2023-05-01 | 2023-09-29 | 110d |  |  |  |  | N/A | N/A | SIT | 5.6 | N/A | Systems Integration Testing (SIT) |  |  |  |  |  |  | -290.67 |
| 604 | 1.4.1.4.1.4.1.1.1 | Develop Test cases |  | 100d | 2023-05-01 A | 2023-09-15 A | 598 | 100% | 2023-05-01 | 2023-09-15 | 100d | 2023-05-01 | 2023-07-28 |  |  | SI Test |  | SIT | 5.6 |  | Systems Integration Testing (SIT) | Complete | COMPLETE |  |  |  |  |  |
| 605 | 1.4.1.4.1.4.1.1.2 | Review Test cases with SIT Working Group |  | 9d | 2023-09-18 A | 2023-09-28 A | 604 | 100% | 2023-09-18 | 2023-09-28 | 9d | 2023-05-26 | 2023-08-25 |  |  | SI Test | PP,IPA | SIT | 5.6 |  | Systems Integration Testing (SIT) | Complete | COMPLETE |  |  |  |  |  |
| 606 | 1.4.1.4.1.4.1.1.3 | SIT Component Integration Testing Test cases Batch 1 (CIT Intervals 1 and 2) approved at ETMAG | milestone | 0d | 2023-09-29 A | 2023-09-29 A | 605FS+1d | 100% | 2023-09-29 | 2023-09-29 | 0d | 2023-09-01 | 2023-09-01 |  |  | SI Test | PP | SIT | 5.6 |  | Systems Integration Testing (SIT) | Complete | COMPLETE | MHHS-ART073 | T3-TE-0069 | SITAG | T3 |  |
| 607 | 1.4.1.4.1.4.1.2 | **Batch 2 (CIT Intervals 3 and 4)** |  | 25d | 2023-10-02 A | 2023-11-03 A |  | 100% | 2023-10-02 | 2023-11-03 | 25d |  |  |  |  | N/A | N/A | SIT | 5.6 | N/A | Systems Integration Testing (SIT) |  |  |  |  |  |  | -290.67 |
| 608 | 1.4.1.4.1.4.1.2.1 | Develop Test cases |  | 15d | 2023-10-02 A | 2023-10-20 A | 606 | 100% | 2023-10-02 | 2023-10-20 | 15d | 2023-05-01 | 2023-07-28 |  |  | SI Test |  | SIT | 5.6 |  | Systems Integration Testing (SIT) | Complete | COMPLETE |  |  |  |  |  |
| 609 | 1.4.1.4.1.4.1.2.2 | Review Test cases with SIT Working Group |  | 9d | 2023-10-23 A | 2023-11-02 A | 608 | 100% | 2023-10-23 | 2023-11-02 | 9d | 2023-05-26 | 2023-08-25 |  |  | SI Test | PP,IPA | SIT | 5.6 |  | Systems Integration Testing (SIT) | Complete | COMPLETE |  |  |  |  |  |
| 610 | 1.4.1.4.1.4.1.2.3 | SIT Component Integration Testing Test cases Batch 2 (CIT Intervals 3 and 4) approved at ETMAG | milestone | 0d | 2023-11-03 A | 2023-11-03 A | 609FS+1d | 100% | 2023-11-03 | 2023-11-03 | 0d | 2023-09-01 | 2023-09-01 |  |  | SI Test | PP | SIT | 5.11 |  | Systems Integration Testing (SIT) | Complete | COMPLETE |  | T3-TE-0104 | SITAG | T3 |  |
| 611 | 1.4.1.4.1.4.1.3 | **Batch 3 (CIT Intervals 5 and 6)** |  | 25d | 2023-11-03 A | 2023-12-08 A |  | 100% | 2023-11-03 | 2023-12-08 | 25d |  |  |  |  | N/A | N/A | SIT | 5.6 | N/A | Systems Integration Testing (SIT) |  |  |  |  |  |  | -290.67 |
| 612 | 1.4.1.4.1.4.1.3.1 | Develop Test cases |  | 15d | 2023-11-03 A | 2023-11-24 A | 610 | 100% | 2023-11-03 | 2023-11-24 | 15d | 2023-05-01 | 2023-07-28 |  |  | SI Test |  | SIT | 5.6 |  | Systems Integration Testing (SIT) | Complete | COMPLETE |  |  |  |  |  |
| 613 | 1.4.1.4.1.4.1.3.2 | Review Test cases with SIT Working Group |  | 9d | 2023-11-27 A | 2023-12-07 A | 612 | 100% | 2023-11-27 | 2023-12-07 | 9d | 2023-05-26 | 2023-08-25 |  |  | SI Test | PP,IPA | SIT | 5.6 |  | Systems Integration Testing (SIT) | Complete | COMPLETE |  |  |  |  |  |
| 614 | 1.4.1.4.1.4.1.3.3 | SIT Component Integration Testing Test cases Batch 3 (CIT Intervals 5 and 6) approved at ETMAG | milestone | 0d | 2023-12-08 A | 2023-12-08 A | 613FS+1d | 100% | 2023-12-08 | 2023-12-08 | 0d | 2023-09-01 | 2023-09-01 |  |  | SI Test | PP | SIT | 5.14 |  | Systems Integration Testing (SIT) | Complete | COMPLETE |  | T3-TE-0105 | SITAG | T3 |  |
| 615 | 1.4.1.4.1.5 | **CIT Interval 1 Preparation** |  | 283d | 2022-11-16 A | 2023-12-15 A |  | 100% | 2022-11-16 | 2023-12-15 | 278d | 2022-11-16 | 2023-10-23 |  | -0 | N/A | N/A | SIT | 5.6 | N/A | Systems Integration Testing (SIT) |  |  |  |  |  |  |  |
| 616 | 1.4.1.4.1.5.1 | **Environments (SIT A)** |  | 246d | 2022-11-16 A | 2023-10-25 A |  | 100% | 2022-11-16 | 2023-10-25 | 239d | 2022-11-16 | 2023-10-06 |  |  | N/A | N/A | SIT | 5.0 | N/A | Systems Integration Testing (SIT) |  |  |  |  |  |  |  |
| 617 | 1.4.1.4.1.5.1.1 | PPs register PKI Officers and request PKI certificates |  | 5d | 2023-10-09 A | 2023-10-13 A |  | 100% | 2023-10-09 | 2023-10-13 | 5d | 2023-08-28 | 2023-09-01 | start no earlier than 2023-10-09 |  | PP | DIP Provider | SIT | 5.5 | Simon Berry | Systems Integration Testing (SIT) | Complete | COMPLETE |  |  |  |  |  |
| 618 | 1.4.1.4.1.5.1.2 | PPs register PKI Officers and request PKI certificates Complete - Interval 1 | milestone | 0d | 2023-10-25 A | 2023-10-25 A | 617FS+8d | 100% | 2023-10-25 | 2023-10-25 | 0d |  |  |  |  | PP | DIP Provider | SIT | 5.10 | Simon Berry | Systems Integration Testing (SIT) | Complete | COMPLETE |  | T3-TE-0094 | SITAG | T3 |  |
| 619 | 1.4.1.4.1.5.1.3 | PP SIT A environment preparation (incl. security certificates and security compliance) |  | 238d | 2022-11-16 A | 2023-10-13 A | 508 | 100% | 2022-11-16 | 2023-10-13 | 208d | 2022-11-16 | 2023-09-01 |  |  | PP | SI Test | SIT | 5.8 | Simon Berry | Systems Integration Testing (SIT) | Complete | COMPLETE |  |  |  |  |  |
| 620 | 1.4.1.4.1.5.1.4 | SI coordinate SIT Participants' SIT A environment preparation |  | 238d | 2022-11-16 A | 2023-10-13 A | 619SS | 100% | 2022-11-16 | 2023-10-13 | 208d | 2022-11-16 | 2023-09-01 |  |  | SI Test | PP | SIT | 5.8 | Simon Berry | Systems Integration Testing (SIT) | Complete | COMPLETE |  |  |  |  |  |
| 621 | 1.4.1.4.1.5.1.5 | PP submit self-declaration of environment preparation complete (incl. security certificates and security compliance) to Programme for assurance | milestone | 0d | 2023-10-13 A | 2023-10-13 A | 619FF | 100% | 2023-10-13 | 2023-10-13 | 0d | 2023-09-01 | 2023-09-01 | start no earlier than 2023-10-13 |  | PP | SI Test | SIT | 5.8 | Simon Berry | Systems Integration Testing (SIT) | Complete | COMPLETE |  |  |  |  |  |
| 622 | 1.4.1.4.1.5.1.6 | SI assure PPs' self-declaration of environment preparation complete (incl. security certificates and security compliance) |  | 5d | 2023-10-16 A | 2023-10-20 A | 621FF+5d | 100% | 2023-10-16 | 2023-10-20 | 5d | 2023-09-04 | 2023-09-08 |  |  | SI Test | PP | SIT | 5.8 | Simon Berry | Systems Integration Testing (SIT) | Complete | COMPLETE |  |  |  |  |  |
| 623 | 1.4.1.4.1.5.1.7 | SIT Participants' SIT A environments ready to start connectivity proving CIT Interval 1 | milestone | 0d | 2023-09-01 A | 2023-09-01 A | 621SS | 100% | 2023-09-01 | 2023-09-01 | 0d | 2023-09-01 | 2023-09-01 |  |  | PP | PP,IPA | SIT | 5.6 | Simon Berry | Systems Integration Testing (SIT) | Complete | COMPLETE | MHHS-ART139 | T3-TE-0019 | SITAG | T3 |  |
| 624 | 1.4.1.4.1.5.1.8 | PP SIT A environment connectivity proving |  | 10d | 2023-09-04 A | 2023-09-15 A | 623 | 100% | 2023-09-04 | 2023-09-15 | 20d | 2023-09-04 | 2023-09-29 |  |  | PP | SI Test | SIT | 5.8 | Simon Berry | Systems Integration Testing (SIT) | Complete | COMPLETE |  |  |  |  |  |
| 625 | 1.4.1.4.1.5.1.9 | SI coordinate SIT Participants' SIT A environment connectivity proving |  | 10d | 2023-09-04 A | 2023-09-15 A | 624SS | 100% | 2023-09-04 | 2023-09-15 | 20d | 2023-09-04 | 2023-09-29 |  |  | SI Test | PP | SIT | 5.8 | Simon Berry | Systems Integration Testing (SIT) | Complete | COMPLETE |  |  |  |  |  |
| 626 | 1.4.1.4.1.5.1.10 | PP deployment of MHHS solution code to SIT A environments |  | 10d | 2023-09-25 A | 2023-10-06 A | 667FF | 100% | 2023-09-25 | 2023-10-06 | 10d | 2023-09-18 | 2023-09-29 |  |  | PP | SI Test | SIT | 5.0 | Simon Berry | Systems Integration Testing (SIT) | Complete | COMPLETE |  |  |  |  |  |
| 627 | 1.4.1.4.1.5.1.11 | SI coordinate deployment of MHHS solution code to SIT Participants' SIT A environments |  | 10d | 2023-09-25 A | 2023-10-06 A | 667FF | 100% | 2023-09-25 | 2023-10-06 | 10d | 2023-09-18 | 2023-09-29 |  |  | SI Test | PP | SIT | 5.0 | Simon Berry | Systems Integration Testing (SIT) | Complete | COMPLETE |  |  |  |  |  |
| 628 | 1.4.1.4.1.5.1.12 | PP submit evidence of SIT A environment connectivity proving and code deployment completion to Programme for assurance |  | 30d | 2023-09-04 A | 2023-10-13 A | 624SS | 100% | 2023-09-04 | 2023-10-13 | 20d | 2023-09-04 | 2023-09-29 |  |  | PP | SI Test | SIT | 5.8 | Simon Berry | Systems Integration Testing (SIT) | Complete | COMPLETE |  |  |  |  |  |
| 629 | 1.4.1.4.1.5.1.13 | SI assurance of SIT Participants' SIT A environment connectivity proving and code deployment completion |  | 25d | 2023-09-18 A | 2023-10-20 A | 628FF+5d | 100% | 2023-09-18 | 2023-10-20 | 25d | 2023-09-04 | 2023-10-06 |  |  | SI Test | PP | SIT | 5.8 | Simon Berry | Systems Integration Testing (SIT) | Complete | COMPLETE |  |  |  |  |  |

Notes:
- 606: Guidance: 18/8 - needs to finish on 29/9 for ETWAG / Action: 18/8 - needs to finish on 29/9 for ETWAG. Update Milestone register after approval
- 610: Guidance: 18/8 - needs to finish on 3/11 for ETWAG / Action: 18/8 - needs to finish on 29/9 for ETWAG
- 614: Guidance: 28/11 - Red because TMAG date has moved from 8/12 to 20/12 due to reduction in Dec TMAGs. No impact. No action

| ID | WBS | Task | Type | Duration | Start | Finish | Predecessors | Complete | Baseline start | Baseline finish | Baseline duration | Baseline cost | Responsible | Involved | Text9 | Task Status | Update Version | MHHS Resource Name | MHHS Programme Phase | Sched Status | RAG | Action | Milestone ID | Text29 | Tier | Artefact ID |
| --- | --- | --- | --- | --- | --- | --- | --- | --- | --- | --- | --- | --- | --- | --- | --- | --- | --- | --- | --- | --- | --- | --- | --- | --- | --- | --- |
| 630 | 1.4.1.4.1.5.2 | **Test Data - ISD Creation** |  | 9d | 2023-08-22 A | 2023-09-01 A |  | 100% | 2023-08-22 | 2023-09-01 | 9d |  | N/A | N/A | SIT | -275.67 | 5.5 | N/A | Systems Integration Testing (SIT) |  |  |  |  |  |  |  |
| 631 | 1.4.1.4.1.5.2.1 | Set-up Market Participants and DIP ID Data |  | 8d | 2023-08-22 A | 2023-08-31 A |  | 100% | 2023-08-22 | 2023-08-31 | 8d |  | SI Test Data | SI Test, DIP, Helix | SIT |  | 5.5 | Cesar Lopes | Systems Integration Testing (SIT) | Complete | COMPLETE |  |  |  |  |  |
| 632 | 1.4.1.4.1.5.2.2 | Distribute ISD Data to Participants |  | 1d | 2023-09-01 A | 2023-09-01 A | 631 | 100% | 2023-09-01 | 2023-09-01 | 1d |  | SI Test Data | SI Test, DIP, Helix | SIT |  | 5.5 | Cesar Lopes | Systems Integration Testing (SIT) | Complete | COMPLETE |  |  |  |  |  |
| 633 | 1.4.1.4.1.5.2.3 | Test Data - ISD Creation Complete | milestone | 0d | 2023-09-01 A | 2023-09-01 A | 632 | 100% | 2023-09-01 | 2023-09-01 | 0d |  | SI Test Data | SI Test, DIP, Helix | SIT |  | 5.5 | Cesar Lopes | Systems Integration Testing (SIT) | Complete | COMPLETE | 3/8 - add as t3 milestones. Awaiting approval at TMAG | T3-TE-0083 | SITAG | T3 |  |
| 634 | 1.4.1.4.1.5.3 | **Test Data - SFTP Onboarding** |  | 70d | 2023-08-21 A | 2023-11-24 A |  | 100% | 2023-08-21 | 2023-11-24 | 70d | -0 | N/A | N/A | SIT | -275.67 | 5.5 | N/A | Systems Integration Testing (SIT) |  |  |  |  |  |  |  |
| 635 | 1.4.1.4.1.5.3.1 | Create Containers and Keys for Participants |  | 3d | 2023-08-21 A | 2023-08-23 A |  | 100% | 2023-08-21 | 2023-08-23 | 3d |  | SI Test Data | SI Test | SIT |  | 5.5 | Cesar Lopes | Systems Integration Testing (SIT) | Complete | COMPLETE |  |  |  |  |  |
| 636 | 1.4.1.4.1.5.3.2 | Share SFTP Access with Participants |  | 5d | 2023-08-24 A | 2023-08-30 A | 635 | 100% | 2023-08-24 | 2023-08-30 | 5d |  | SI Test Data | SI Test, PP | SIT |  | 5.5 | Cesar Lopes | Systems Integration Testing (SIT) | Complete | COMPLETE |  |  |  |  |  |
| 637 | 1.4.1.4.1.5.3.3 | Test SFTP Connectivity |  | 5d | 2023-08-31 A | 2023-09-06 A | 636 | 100% | 2023-08-31 | 2023-09-06 | 5d |  | SI Test Data | SI Test, PP | SIT |  | 5.5 | Cesar Lopes | Systems Integration Testing (SIT) | Complete | COMPLETE |  |  |  |  |  |
| 638 | 1.4.1.4.1.5.3.4 | Test Data - SFTP Onboarding Complete | milestone | 0d | 2023-11-24 A | 2023-11-24 A | 637FS+57d | 100% | 2023-11-24 | 2023-11-24 | 0d |  | SI Test Data | SI Test, PP | SIT |  | 5.13 | Cesar Lopes | Systems Integration Testing (SIT) | Complete | COMPLETE |  | T3-TE-0084 | SITAG | T3 |  |
| 639 | 1.4.1.4.1.5.4 | **Test Data - Provide Sample Files** |  | 10d | 2023-08-21 A | 2023-09-01 A |  | 100% | 2023-08-21 | 2023-09-01 | 10d |  | N/A | N/A | SIT | -275.67 | 5.5 | N/A | Systems Integration Testing (SIT) |  |  |  |  |  |  |  |
| 640 | 1.4.1.4.1.5.4.1 | Generate Sample Files off IF Messages |  | 8d | 2023-08-21 A | 2023-08-30 A |  | 100% | 2023-08-21 | 2023-08-30 | 8d |  | SI Test Data | SI Test | SIT |  | 5.5 | Cesar Lopes | Systems Integration Testing (SIT) | Complete | COMPLETE |  |  |  |  |  |
| 641 | 1.4.1.4.1.5.4.2 | Transmit Sample Files off IF Messages to Participants (More detail needs to be planned for a POC) |  | 2d | 2023-08-31 A | 2023-09-01 A | 640 | 100% | 2023-08-31 | 2023-09-01 | 2d |  | SI Test Data | SI Test | SIT |  | 5.5 | Cesar Lopes | Systems Integration Testing (SIT) | Complete | COMPLETE |  |  |  |  |  |
| 642 | 1.4.1.4.1.5.4.3 | Test Data - Provide Sample Files Complete | milestone | 0d | 2023-09-01 A | 2023-09-01 A | 641 | 100% | 2023-09-01 | 2023-09-01 | 0d |  | SI Test Data | SI Test | SIT |  | 5.5 | Cesar Lopes | Systems Integration Testing (SIT) | Complete | COMPLETE | 3/8 - add as t3 milestones. Awaiting approval at TMAG | T3-TE-0085 | SITAG | T3 |  |
| 643 | 1.4.1.4.1.5.5 | **Test Data - Detailed SIT Data Load Guidance** |  | 65d | 2023-09-07 A | 2023-12-06 A |  | 100% | 2023-09-07 | 2023-12-06 | 62d | -0 | N/A | N/A | SIT | -275.67 | 5.5 | N/A | Systems Integration Testing (SIT) |  |  |  |  |  |  |  |
| 644 | 1.4.1.4.1.5.5.1 | Document Guidance |  | 21d | 2023-09-07 A | 2023-10-05 A | 642FS+3d | 100% | 2023-09-07 | 2023-10-05 | 16d |  | SI Test Data | SI Test | SIT |  | 5.9 | Cesar Lopes | Systems Integration Testing (SIT) | Complete | COMPLETE |  |  |  |  |  |
| 645 | 1.4.1.4.1.5.5.2 | Provide Guidance to PPs |  | 1d | 2023-10-06 A | 2023-10-06 A | 644 | 100% | 2023-10-06 | 2023-10-06 | 1d |  | SI Test Data | SI Test | SIT |  | 5.9 | Cesar Lopes | Systems Integration Testing (SIT) | Complete | COMPLETE |  |  |  |  |  |
| 646 | 1.4.1.4.1.5.5.3 | Test Data - Detailed SIT Functional Data Load Guidance Complete | milestone | 0d | 2023-12-06 A | 2023-12-06 A | 645FS+43d | 100% | 2023-12-06 | 2023-12-06 | 0d |  | SI Test Data | SI Test | SIT |  | 5.13 | Richard Puddephatt | Systems Integration Testing (SIT) | Complete | COMPLETE |  | T3-TE-0095 | SITAG | T3 | MHHS-DEL 1545 |
| 647 | 1.4.1.4.1.5.6 | **Test Data - Population of Data Items for Testing Guidance - Draft** |  | 80d | 2023-08-17 A | 2023-12-06 A |  | 100% | 2023-08-17 | 2023-12-06 | 77d | -0 | N/A | N/A | SIT | -275.67 | 5.5 | N/A | Systems Integration Testing (SIT) |  |  |  |  |  |  |  |
| 648 | 1.4.1.4.1.5.6.1 | Document Guidance - Draft |  | 11d | 2023-08-17 A | 2023-08-31 A | 837 | 100% | 2023-08-17 | 2023-08-31 | 11d |  | SI Test Data | SI Test | SIT |  | 5.6 | Cesar Lopes | Systems Integration Testing (SIT) | Complete | COMPLETE |  |  |  |  |  |
| 649 | 1.4.1.4.1.5.6.2 | Provide Guidance to PPs - Draft |  | 1d | 2023-09-01 A | 2023-09-01 A | 648 | 100% | 2023-09-01 | 2023-09-01 | 1d |  | SI Test Data | SI Test | SIT |  | 5.6 | Cesar Lopes | Systems Integration Testing (SIT) | Complete | COMPLETE |  |  |  |  |  |
| 650 | 1.4.1.4.1.5.6.3 | Test Data - Population of Data Items for Testing Guidance - Draft Complete | milestone | 0d | 2023-12-06 A | 2023-12-06 A | 649FS+68d | 100% | 2023-12-06 | 2023-12-06 | 0d |  | SI Test Data | SI Test | SIT |  | 5.13 | Richard Puddephatt | Systems Integration Testing (SIT) | Complete | COMPLETE |  | T3-TE-0096 | SITAG | T3 | MHHS-DEL 816 |
| 651 | 1.4.1.4.1.5.7 | **Test Data - Population of Data Items for Testing Guidance - Final** |  | 87d | 2023-08-17 A | 2023-12-15 A |  | 100% | 2023-08-17 | 2023-12-15 | 45d |  | N/A | N/A | SIT | -275.67 | 5.5 | N/A | Systems Integration Testing (SIT) |  |  |  |  |  |  |  |
| 652 | 1.4.1.4.1.5.7.1 | Update Document Guidance With PPS Feedback |  | 81d | 2023-08-17 A | 2023-12-07 A | 648SS | 100% | 2023-08-17 | 2023-12-07 | 44d |  | SI Test Data | SI Test | SIT |  | 5.5 | Richard Puddephatt | Systems Integration Testing (SIT) | Complete | COMPLETE |  |  |  |  |  |
| 653 | 1.4.1.4.1.5.7.2 | Provide Final Guidance to PPs |  | 1d | 2023-12-08 A | 2023-12-08 A | 652 | 100% | 2023-12-08 | 2023-12-08 | 1d |  | SI Test Data | SI Test | SIT |  | 5.5 | Richard Puddephatt | Systems Integration Testing (SIT) | Complete | COMPLETE |  |  |  |  |  |
| 654 | 1.4.1.4.1.5.7.3 | Test Data - Population of Data Items for Testing Guidance - Final Complete | milestone | 0d | 2023-12-15 A | 2023-12-15 A | 653FS+5d | 100% | 2023-12-15 | 2023-12-15 | 0d |  | SI Test Data | SI Test | SIT |  | 5.14 | Richard Puddephatt | Systems Integration Testing (SIT) | Complete | COMPLETE |  | T3-TE-0097 | SITAG | T3 | MHHS-DEL 816 |

| ID | WBS | Task | Type | Duration | Start | Finish | Predecessors | Complete | Baseline start | Baseline finish | Baseline duration | Baseline 1 start | Baseline 1 finish | Constraint | Baseline cost | Responsible | Involved | Text9 | Update Version | MHHS Resource Name | MHHS Programme Phase | Sched Status | RAG | Artefact ID | Milestone ID | Text29 | Tier |
| --- | --- | --- | --- | --- | --- | --- | --- | --- | --- | --- | --- | --- | --- | --- | --- | --- | --- | --- | --- | --- | --- | --- | --- | --- | --- | --- | --- |
| 655 | 1.4.1.4.1.5.8 | **Test Data (SIT A) Interval 1** |  | 40d | 2023-09-04 A | 2023-10-27 A |  | 100% | 2023-09-04 | 2023-10-27 | 20d | 2023-09-04 | 2023-09-29 |  |  | N/A | N/A | SIT | 5.0 | N/A | Systems Integration Testing (SIT) |  |  |  |  |  |  |
| 656 | 1.4.1.4.1.5.8.1 | Run data allocation |  | 4d | 2023-09-04 A | 2023-09-07 A | 596, 633 | 100% | 2023-09-04 | 2023-09-07 | 4d | 2023-09-04 | 2023-09-07 |  |  | SI Test |  | SIT | 5.0 | Cesar Lopes | Systems Integration Testing (SIT) | Complete | COMPLETE |  |  |  |  |
| 657 | 1.4.1.4.1.5.8.2 | Cleanse, anonymise and populate data post cut |  | 4d | 2023-09-08 A | 2023-09-13 A | 656 | 100% | 2023-09-08 | 2023-09-13 | 4d | 2023-09-08 | 2023-09-13 |  |  | SI Test |  | SIT | 5.0 | Cesar Lopes | Systems Integration Testing (SIT) | Complete | COMPLETE |  |  |  |  |
| 658 | 1.4.1.4.1.5.8.3 | Transmit data sets to PPs |  | 3d | 2023-09-15 A | 2023-09-19 A | 657 | 100% | 2023-09-15 | 2023-09-19 | 1d | 2023-09-14 | 2023-09-15 |  |  | SI Test |  | SIT | 5.0 | Cesar Lopes | Systems Integration Testing (SIT) | Complete | COMPLETE |  |  |  |  |
| 659 | 1.4.1.4.1.5.8.4 | PP - Load test data to test environments |  | 7d | 2023-09-20 A | 2023-09-28 A | 658, 642 | 100% | 2023-09-20 | 2023-09-28 | 5d | 2023-09-18 | 2023-09-22 |  |  | PP |  | SIT | 5.0 | Cesar Lopes | Systems Integration Testing (SIT) | Complete | COMPLETE |  |  |  |  |
| 660 | 1.4.1.4.1.5.8.5 | PP Check data integrity on test environment |  | 1d | 2023-09-29 A | 2023-09-29 A | 659 | 100% | 2023-09-29 | 2023-09-29 | 5d | 2023-09-25 | 2023-09-29 |  |  | PP |  | SIT | 5.0 | Cesar Lopes | Systems Integration Testing (SIT) | Complete | COMPLETE |  |  |  |  |
| 661 | 1.4.1.4.1.5.8.6 | PP submit self-declaration to Programme to confirm loading & verification of test data | milestone | 0d | 2023-09-29 A | 2023-09-29 A | 660FF | 100% | 2023-09-29 | 2023-09-29 | 0d | 2023-09-29 | 2023-09-29 |  |  | PP | SI Test | SIT | 5.0 | Cesar Lopes | Systems Integration Testing (SIT) | Complete | COMPLETE |  |  |  |  |
| 662 | 1.4.1.4.1.5.8.7 | Test Data (SIT A) Interval 1 Complete | milestone | 0d | 2023-10-27 A | 2023-10-27 A | 661FS+20d | 100% | 2023-10-27 | 2023-10-27 | 0d |  |  |  |  | SI Test | PP | SIT | 5.10 | Cesar Lopes | Systems Integration Testing (SIT) | Complete | COMPLETE | MHHS-ART148/169 | T3-TE-0073 | SITAG | T3 |
| 663 | 1.4.1.4.1.5.9 | **Other Preparation** |  | 45d | 2023-07-03 A | 2023-09-01 A |  | 100% | 2023-07-03 | 2023-09-01 | 45d | 2023-07-03 | 2023-09-01 |  |  | N/A | N/A | SIT | 5.0 | N/A | Systems Integration Testing (SIT) |  |  |  |  |  |  |
| 664 | 1.4.1.4.1.5.9.1 | Onboarding of Test Participants to Test Management Tool (Azure DevOps) |  | 45d | 2023-07-03 A | 2023-09-01 A | 623SF | 100% | 2023-07-03 | 2023-09-01 | 45d | 2023-07-03 | 2023-09-01 |  |  | SI Test | PP | SIT | 5.0 |  | Systems Integration Testing (SIT) | Complete | COMPLETE |  |  |  |  |
| 665 | 1.4.1.4.1.5.9.2 | Test Management Tool onboarding |  | 45d | 2023-07-03 A | 2023-09-01 A | 623SF | 100% | 2023-07-03 | 2023-09-01 | 45d | 2023-07-03 | 2023-09-01 |  |  | PP | SI Test | SIT | 5.0 |  | Systems Integration Testing (SIT) | Complete | COMPLETE |  |  |  |  |
| 666 | 1.4.1.4.1.5.10 | **SIT Component Integration Test Readiness Report** |  | 28d | 2023-09-14 A | 2023-10-23 A |  | 100% | 2023-09-14 | 2023-10-23 | 9d | 2023-09-11 | 2023-10-20 |  |  | N/A | N/A | SIT | 5.6 | N/A | Systems Integration Testing (SIT) |  |  |  |  |  |  |
| 667 | 1.4.1.4.1.5.10.1 | PP submit Test Readiness Report to Programme for assurance | milestone | 0d | 2023-10-20 A | 2023-10-20 A | 665, 606, 662 | 100% | 2023-10-20 | 2023-10-20 | 0d | 2023-09-29 | 2023-09-29 | start no earlier than 2023-10-09 |  | PP | SI Test | SIT | 5.6 |  | Systems Integration Testing (SIT) | Complete | COMPLETE |  |  |  |  |
| 668 | 1.4.1.4.1.5.10.2 | SI assure Test Participants' Test Readiness Reports |  | 1d | 2023-10-23 A | 2023-10-23 A | 667SS | 100% | 2023-10-23 | 2023-10-23 | 5d | 2023-10-02 | 2023-10-06 |  |  | SI Test | PP,IPA | SIT | 5.6 |  | Systems Integration Testing (SIT) | Complete | COMPLETE |  |  |  |  |
| 669 | 1.4.1.4.1.5.10.3 | SI develop Overarching SIT Component Integration Test Readiness Report |  | 23d | 2023-09-14 A | 2023-10-16 A | 592FS+40d | 100% | 2023-09-14 | 2023-10-16 | 4d | 2023-09-11 | 2023-10-06 |  |  | SI Test |  | SIT | 5.6 |  | Systems Integration Testing (SIT) | Complete | COMPLETE |  |  |  |  |
| 670 | 1.4.1.4.1.5.10.4 | Artefact review (via TMAG) and updates |  | 4d | 2023-10-17 A | 2023-10-20 A | 669 | 100% | 2023-10-17 | 2023-10-20 | 5d | 2023-10-09 | 2023-10-20 |  |  | SI Test | PP,IPA | SIT | 5.6 |  | Systems Integration Testing (SIT) | Complete | COMPLETE |  |  |  |  |
| 671 | 1.4.1.4.1.5.11 | SIT Component Integration Testing 1 Preparation Complete (incl. approval of SI SIT Component Integration Test Readiness Report) | milestone | 0d | 2023-10-27 A | 2023-10-27 A | 670FS+1d, 667, 623, 665, 662, 240, 245, 234, 254, 255, 668 | 100% | 2023-10-27 | 2023-10-27 | 0d | 2023-10-23 | 2023-10-23 |  |  | SI Test | PP,IPA | SIT | 5.11 |  | Systems Integration Testing (SIT) | Complete | COMPLETE | MHHS-ART071 | T2-TE-0250 | SITAG | T2 |
| 672 | 1.4.1.4.1.6 | **CIT Interval 2 Preparation** |  | 103d | 2023-07-03 A | 2023-11-22 A |  | 100% | 2023-07-03 | 2023-11-22 | 95d | 2022-11-16 | 2023-11-06 |  | -0 | N/A | N/A | SIT | 5.0 | N/A | Systems Integration Testing (SIT) |  |  |  |  |  |  |
| 673 | 1.4.1.4.1.6.1 | **Environments (SIT A)** |  | 43d | 2023-09-22 A | 2023-11-22 A |  | 100% | 2023-09-22 | 2023-11-22 | 35d | 2022-11-16 | 2023-10-27 |  | -0 | N/A | N/A | SIT | 5.0 | N/A | Systems Integration Testing (SIT) |  |  |  |  |  |  |
| 674 | 1.4.1.4.1.6.1.1 | SIT Participants' SIT A environments ready to start connectivity proving CIT Interval 2 | milestone | 0d | 2023-09-22 A | 2023-09-22 A |  | 100% | 2023-09-22 | 2023-09-22 | 0d | 2023-09-22 | 2023-09-22 |  |  | PP | PP,IPA | SIT | 5.6 | Simon Berry | Systems Integration Testing (SIT) | Complete | COMPLETE | MHHS-ART139 | T3-TE-0020 | SITAG | T3 |
| 675 | 1.4.1.4.1.6.1.2 | Programme Participants Ready to Start Connectivity Proving | milestone | 0d | 2023-09-22 A | 2023-09-22 A |  | 100% | 2023-09-22 | 2023-09-22 | 0d |  |  | finish no earlier than 2023-09-22 |  | PP |  | SIT | 5.10 | Simon Berry | Systems Integration Testing (SIT) | Complete | COMPLETE |  |  |  |  |
| 676 | 1.4.1.4.1.6.1.3 | Internal Connectivity Proving Phase |  | 10d | 2023-09-25 A | 2023-10-06 A | 675 | 100% | 2023-09-25 | 2023-10-06 | 10d |  |  |  |  | PP |  | SIT | 5.10 | Simon Berry | Systems Integration Testing (SIT) | Complete | COMPLETE |  |  |  |  |
| 677 | 1.4.1.4.1.6.1.4 | Internal Connectivity Proving Phase Complete | milestone | 0d | 2023-10-06 A | 2023-10-06 A | 676 | 100% | 2023-10-06 | 2023-10-06 | 0d |  |  | start no earlier than 2023-10-06 |  | PP |  | SIT | 5.10 | Simon Berry | Systems Integration Testing (SIT) | Complete | COMPLETE |  |  |  |  |
| 678 | 1.4.1.4.1.6.1.5 | DIP Onboarding Activity (1. PKI Officers and Certificates, 2. Set-up Validation, 3. End Point Creation, 4. Controlled Smoke Test ) |  | 28d | 2023-10-16 A | 2023-11-22 A | 677FS+5d | 100% | 2023-10-16 | 2023-11-22 | 20d |  |  |  |  | PP |  | SIT | 5.10 | Simon Berry | Systems Integration Testing (SIT) | Complete | COMPLETE |  |  |  |  |
| 679 | 1.4.1.4.1.6.1.6 | DIP Onboarding Complete | milestone | 0d | 2023-11-22 A | 2023-11-22 A | 678 | 100% | 2023-11-22 | 2023-11-22 | 0d |  |  |  |  | PP |  | SIT | 5.10 | Simon Berry | Systems Integration Testing (SIT) | Complete | COMPLETE |  |  |  |  |
| 680 | 1.4.1.4.1.6.1.7 | PPs Register PKI Officers and request PKI certificates Complete - Interval 2 | milestone | 0d | 2023-11-22 A | 2023-11-22 A | 679 | 100% | 2023-11-22 | 2023-11-22 | 0d |  |  |  |  | PP | DIP Provider | SIT | 5.15 | Simon Berry | Systems Integration Testing (SIT) | Complete | COMPLETE |  | T3-TE-0098 | SITAG | T3 |
| 681 | 1.4.1.4.1.6.1.8 | PP Code Deployment | milestone | 0d | 2023-10-20 A | 2023-10-20 A |  | 100% | 2023-10-20 | 2023-10-20 | 0d |  |  | start no earlier than 2023-10-20 |  | PP |  | SIT | 5.10 | Simon Berry | Systems Integration Testing (SIT) | Complete | COMPLETE |  |  |  |  |

Notes:
- 662: Action: 28/7: CH: Needs to be set-up as a reporting milestone. 31/7: Check with Cesar if has been approved so can be baselined
- 666: Action: 21/8 - Rework with Lee
- 668: Action: 21/8 - Rework with Lee
- 669: Action: 21/8 - Rework with Lee
- 670: Action: 21/8 - Rework with Lee

| ID | WBS | Task | Type | Duration | Start | Finish | Predecessors | Complete | Baseline start | Baseline finish | Baseline duration | Baseline 1 start | Baseline 1 finish | Constraint | Baseline cost | Responsible | Involved | Text9 | Update Version | MHHS Resource Name | MHHS Programme Phase | Sched Status | RAG | Artefact ID | Milestone ID | Text29 | Tier |
| --- | --- | --- | --- | --- | --- | --- | --- | --- | --- | --- | --- | --- | --- | --- | --- | --- | --- | --- | --- | --- | --- | --- | --- | --- | --- | --- | --- |
| 682 | 1.4.1.4.1.6.2 | **Test Data (SIT A) Interval 2** |  | 43d | 2023-09-20 A | 2023-11-17 A |  | 100% | 2023-09-20 | 2023-11-17 | 25d | 2023-09-18 | 2023-10-20 |  |  | N/A | N/A | SIT | 5.0 | N/A | Systems Integration Testing (SIT) |  |  |  |  |  |  |
| 683 | 1.4.1.4.1.6.2.1 | Run data allocation |  | 7d | 2023-09-20 A | 2023-09-28 A | 659SS | 100% | 2023-09-20 | 2023-09-28 | 5d | 2023-09-18 | 2023-09-22 |  |  | SI Test |  | SIT | 5.0 | Cesar Lopes | Systems Integration Testing (SIT) | Complete | COMPLETE |  |  |  |  |
| 684 | 1.4.1.4.1.6.2.2 | Cleanse and populate data post cut |  | 2d | 2023-09-29 A | 2023-10-02 A | 683 | 100% | 2023-09-29 | 2023-10-02 | 5d | 2023-09-25 | 2023-09-29 |  |  | SI Test |  | SIT | 5.0 | Cesar Lopes | Systems Integration Testing (SIT) | Complete | COMPLETE |  |  |  |  |
| 685 | 1.4.1.4.1.6.2.3 | Transmit data sets to PPs |  | 1d | 2023-10-03 A | 2023-10-03 A | 684 | 100% | 2023-10-03 | 2023-10-03 | 2d | 2023-10-02 | 2023-10-03 |  |  | SI Test |  | SIT | 5.0 | Cesar Lopes | Systems Integration Testing (SIT) | Complete | COMPLETE |  |  |  |  |
| 686 | 1.4.1.4.1.6.2.4 | PP - Load test data to test environments |  | 33d | 2023-10-04 A | 2023-11-17 A | 685 | 100% | 2023-10-04 | 2023-11-17 | 8d | 2023-10-04 | 2023-10-13 |  |  | PP |  | SIT | 5.0 | Cesar Lopes | Systems Integration Testing (SIT) | Complete | COMPLETE |  |  |  |  |
| 687 | 1.4.1.4.1.6.2.5 | PP Check data integrity on test environment |  | 15d | 2023-10-23 A | 2023-11-17 A | 686FF | 100% | 2023-10-23 | 2023-11-17 | 5d | 2023-10-16 | 2023-10-20 |  |  | PP |  | SIT | 5.0 | Cesar Lopes | Systems Integration Testing (SIT) | Complete | COMPLETE |  |  |  |  |
| 688 | 1.4.1.4.1.6.2.6 | PP submit self-declaration to Programme to confirm loading & verification of test data | milestone | 0d | 2023-11-17 A | 2023-11-17 A | 687FF | 100% | 2023-11-17 | 2023-11-17 | 0d | 2023-10-20 | 2023-10-20 |  |  | PP | SI Test | SIT | 5.0 | Cesar Lopes | Systems Integration Testing (SIT) | Complete | COMPLETE |  |  |  |  |
| 689 | 1.4.1.4.1.6.2.7 | Test Data (SIT A) Interval 2 Complete | milestone | 0d | 2023-11-17 A | 2023-11-17 A | 688 | 100% | 2023-11-17 | 2023-11-17 | 0d |  |  |  |  | SI Test | PP | SIT | 5.12 | Cesar Lopes | Systems Integration Testing (SIT) | Complete | COMPLETE | MHHS-ART148/169 | T3-TE-0074 | SITAG | T3 |
| 690 | 1.4.1.4.1.6.3 | **Other Preparation** |  | 87d | 2023-07-03 A | 2023-10-31 A |  | 100% | 2023-07-03 | 2023-10-31 | 87d | 2023-07-03 | 2023-09-22 |  | -0 | N/A | N/A | SIT | 5.0 | N/A | Systems Integration Testing (SIT) |  |  |  |  |  |  |
| 691 | 1.4.1.4.1.6.3.1 | Onboarding of Test Participants to Test Management Tool (Azure DevOps) |  | 60d | 2023-07-03 A | 2023-09-22 A | 674SF | 100% | 2023-07-03 | 2023-09-22 | 60d | 2023-07-03 | 2023-09-22 |  |  | SI Test | PP | SIT | 5.0 |  | Systems Integration Testing (SIT) | Complete | COMPLETE |  |  |  |  |
| 692 | 1.4.1.4.1.6.3.2 | Test Management Tool onboarding |  | 27d | 2023-09-25 A | 2023-10-31 A | 691 | 100% | 2023-09-25 | 2023-10-31 | 27d | 2023-07-03 | 2023-09-22 |  |  | PP | SI Test | SIT | 5.0 | Simon Berry | Systems Integration Testing (SIT) | Complete | COMPLETE |  |  |  |  |
| 693 | 1.4.1.4.1.6.4 | **SIT Component Integration Test Readiness Report** |  | 25d | 2023-10-02 A | 2023-11-03 A |  | 100% | 2023-10-02 | 2023-11-03 | 25d | 2023-10-02 | 2023-11-03 |  |  | N/A | N/A | SIT | 5.0 | N/A | Systems Integration Testing (SIT) |  |  |  |  |  |  |
| 694 | 1.4.1.4.1.6.4.1 | PP submit Test Readiness Report to Programme for assurance | milestone | 0d | 2023-10-25 A | 2023-10-25 A | 606FS+18d | 100% | 2023-10-25 | 2023-10-25 | 0d | 2023-10-20 | 2023-10-20 |  |  | PP | SI Test | SIT | 5.0 |  | Systems Integration Testing (SIT) | Complete | COMPLETE |  |  |  |  |
| 695 | 1.4.1.4.1.6.4.2 | SI assure Test Participants' Test Readiness Reports |  | 2d | 2023-10-26 A | 2023-10-27 A | 694 | 100% | 2023-10-26 | 2023-10-27 | 5d | 2023-10-23 | 2023-10-27 |  |  | SI Test | PP,IPA | SIT | 5.0 |  | Systems Integration Testing (SIT) | Complete | COMPLETE |  |  |  |  |
| 696 | 1.4.1.4.1.6.4.3 | SI develop Overarching SIT Component Integration Test Readiness Report |  | 20d | 2023-10-02 A | 2023-10-27 A | 695FF | 100% | 2023-10-02 | 2023-10-27 | 20d | 2023-10-02 | 2023-10-27 |  |  | SI Test |  | SIT | 5.0 |  | Systems Integration Testing (SIT) | Complete | COMPLETE |  |  |  |  |
| 697 | 1.4.1.4.1.6.4.4 | Artefact review (via TMAG) and updates |  | 5d | 2023-10-30 A | 2023-11-03 A | 696 | 100% | 2023-10-30 | 2023-11-03 | 5d | 2023-10-30 | 2023-11-03 |  |  | SI Test | PP,IPA | SIT | 5.0 |  | Systems Integration Testing (SIT) | Complete | COMPLETE |  |  |  |  |
| 698 | 1.4.1.4.1.6.5 | SIT Component Integration Testing 2 Preparation Complete (incl. approval of SI SIT Component Integration Test Readiness Report) | milestone | 0d | 2023-11-06 A | 2023-11-06 A | 692, 697FS+1d, 674, 303 | 100% | 2023-11-06 | 2023-11-06 | 0d | 2023-11-06 | 2023-11-06 |  |  | SI Test | PP,IPA | SIT | 5.11 |  | Systems Integration Testing (SIT) | Complete | COMPLETE | MHHS-ART071 | T2-TE-0300 | SITAG | T2 |
| 699 | 1.4.1.4.1.7 | **CIT Interval 3 Preparation** |  | 54d | 2023-10-03 A | 2023-12-15 A |  | 100% | 2023-10-03 | 2023-12-15 | 91d | 2022-11-16 | 2023-11-20 |  | -0 | N/A | N/A | SIT | 5.0 | N/A | Systems Integration Testing (SIT) |  |  |  |  |  |  |
| 700 | 1.4.1.4.1.7.1 | **PIT Test Completion Report (incl. evidence)** |  | 26d | 2023-10-13 A | 2023-11-17 A |  | 100% | 2023-10-13 | 2023-11-17 | 21d | 2023-10-13 | 2023-11-10 |  |  | N/A | N/A | SIT | 5.0 | N/A | Systems Integration Testing (SIT) |  |  |  |  |  |  |
| 701 | 1.4.1.4.1.7.1.1 | Submit draft PIT Test Completion Report (incl. evidence) and submit to Programme for assurance |  | 11d | 2023-10-13 A | 2023-10-27 A |  | 100% | 2023-10-13 | 2023-10-27 | 1d | 2023-10-13 | 2023-10-13 | must start on 2023-10-13 |  | PP | SI Test | SIT | 5.0 |  | Systems Integration Testing (SIT) | Complete | COMPLETE |  |  |  |  |
| 702 | 1.4.1.4.1.7.1.2 | Finalise PIT Test Completion Report (incl. evidence) |  | 5d | 2023-10-30 A | 2023-11-03 A | 701 | 100% | 2023-10-30 | 2023-11-03 | 15d | 2023-10-16 | 2023-11-03 |  |  | PP | SI Test | SIT | 5.0 |  | Systems Integration Testing (SIT) | Complete | COMPLETE |  |  |  |  |
| 703 | 1.4.1.4.1.7.1.3 | PP PIT Completion Report (excl. Migration/Reverse Migration) submitted to Programme for assurance CIT Interval 3 | milestone | 0d | 2023-11-03 A | 2023-11-03 A | 702, 79, 95 | 100% | 2023-11-03 | 2023-11-03 | 0d | 2023-11-03 | 2023-11-03 |  |  | PP | SI Test | SIT | 5.11 |  | Systems Integration Testing (SIT) | Complete | COMPLETE |  | T3-DB-0017 | SITAG | T3 |
| 704 | 1.4.1.4.1.7.1.4 | PP Final PIT Completion Reports assured by SI |  | 10d | 2023-11-06 A | 2023-11-17 A | 703 | 100% | 2023-11-06 | 2023-11-17 | 5d | 2023-11-06 | 2023-11-10 |  |  | SI Test | PP | SIT | 5.0 |  | Systems Integration Testing (SIT) | Complete | COMPLETE |  |  |  |  |
| 705 | 1.4.1.4.1.7.2 | **Environments (SIT A)** |  | 51d | 2023-10-06 A | 2023-12-15 A |  | 100% | 2023-10-06 | 2023-12-15 | 26d | 2022-11-16 | 2023-11-10 |  | -0 | N/A | N/A | SIT | 5.0 | N/A | Systems Integration Testing (SIT) |  |  |  |  |  |  |
| 706 | 1.4.1.4.1.7.2.1 | Programme Participants Ready to Start Connectivity Proving | milestone | 0d | 2023-10-06 A | 2023-10-06 A |  | 100% | 2023-10-06 | 2023-10-06 | 0d |  |  | start no earlier than 2023-10-06 |  | PP | PP.SI Test | SIT | 5.10 | Simon Berry | Systems Integration Testing (SIT) | Complete | COMPLETE |  |  |  |  |
| 707 | 1.4.1.4.1.7.2.2 | SIT Participants' SIT A environments ready to start connectivity proving CIT Interval 3 | milestone | 0d | 2023-10-06 A | 2023-10-06 A | 706 | 100% | 2023-10-06 | 2023-10-06 | 0d | 2023-10-06 | 2023-10-06 |  |  | PP | PP,SI Test | SIT | 5.10 | Simon Berry | Systems Integration Testing (SIT) | Complete | COMPLETE | MHHS-ART139 | T3-TE-0021 | SITAG | T3 |
| 708 | 1.4.1.4.1.7.2.3 | Internal Connectivity Proving Phase |  | 10d | 2023-10-09 A | 2023-10-20 A | 706FS+1d | 100% | 2023-10-09 | 2023-10-20 | 10d |  |  |  |  | PP | PP,SI Test | SIT | 5.10 | Simon Berry | Systems Integration Testing (SIT) | Complete | COMPLETE |  |  |  |  |
| 709 | 1.4.1.4.1.7.2.4 | Internal Connectivity Proving Phase Complete | milestone | 0d | 2023-10-20 A | 2023-10-20 A | 708 | 100% | 2023-10-20 | 2023-10-20 | 0d |  |  |  |  | PP | PP,SI Test | SIT | 5.10 | Simon Berry | Systems Integration Testing (SIT) | Complete | COMPLETE |  |  |  |  |
| 710 | 1.4.1.4.1.7.2.5 | DIP Onboarding Activity (1. PKI Officers and Certificates, 2. Set-up Validation, 3. End Point Creation, 4. Controlled Smoke Test ) |  | 35d | 2023-10-30 A | 2023-12-15 A | 709FS+5d | 100% | 2023-10-30 | 2023-12-15 | 10d |  |  |  |  | PP | PP,DIP Provider | SIT | 5.10 | Simon Berry | Systems Integration Testing (SIT) | Complete | COMPLETE |  |  |  |  |
| 711 | 1.4.1.4.1.7.2.6 | DIP Onboarding Complete | milestone | 0d | 2023-12-15 A | 2023-12-15 A | 710 | 100% | 2023-12-15 | 2023-12-15 | 0d |  |  |  |  | PP | PP,DIP Provider | SIT | 5.10 | Simon Berry | Systems Integration Testing (SIT) | Complete | COMPLETE |  |  |  |  |
| 712 | 1.4.1.4.1.7.2.7 | PPs Register PKI Officers and Request PKI certificates Complete - Interval 3 | milestone | 0d | 2023-12-15 A | 2023-12-15 A | 711FF | 100% | 2023-12-15 | 2023-12-15 | 0d | 2023-10-02 | 2023-10-06 |  |  | PP | PP,DIP Provider | SIT | 5.13 | Simon Berry | Systems Integration Testing (SIT) | Complete | COMPLETE |  | T3-TE-0099 | SITAG | T3 |
| 713 | 1.4.1.4.1.7.2.8 | PP Code Deployment | milestone | 0d | 2023-11-10 A | 2023-11-10 A | 709FS+15d | 100% | 2023-11-10 | 2023-11-10 | 0d |  |  | start no earlier than 2023-10-20 |  | PP | PP | SIT | 5.10 | Simon Berry | Systems Integration Testing (SIT) | Complete | COMPLETE |  |  |  |  |

Notes:
- 689: Action: 28/7: CH: Needs to be set-up as a reporting milestone. 31/7: Check with Cesar if has been approved so can be baselined
- 707: Action: 30/8 - lee said date is 30/10

| ID | WBS | Task | Type | Duration | Start | Finish | Predecessors | Complete | Baseline start | Baseline finish | Baseline duration | Baseline 1 start | Baseline 1 finish | Constraint | Baseline cost | Responsible | Involved | Text9 | Update Version | MHHS Resource Name | MHHS Programme Phase | Sched Status | RAG | Artefact ID | Milestone ID | Text29 | Tier |
| --- | --- | --- | --- | --- | --- | --- | --- | --- | --- | --- | --- | --- | --- | --- | --- | --- | --- | --- | --- | --- | --- | --- | --- | --- | --- | --- | --- |
| 714 | 1.4.1.4.1.7.3 | **Test Data (SIT A) Interval 3** |  | 34d | 2023-10-03 A | 2023-11-17 A |  | 100% | 2023-10-03 | 2023-11-17 | 25d | 2023-10-02 | 2023-11-03 |  |  | N/A | N/A | SIT | 5.0 | N/A | Systems Integration Testing (SIT) |  |  |  |  |  |  |
| 715 | 1.4.1.4.1.7.3.1 | Run data allocation |  | 4d | 2023-10-03 A | 2023-10-06 A | 685SS | 100% | 2023-10-03 | 2023-10-06 | 5d | 2023-10-02 | 2023-10-06 |  |  | SI Test |  | SIT | 5.0 | Cesar Lopes | Systems Integration Testing (SIT) | Complete | COMPLETE |  |  |  |  |
| 716 | 1.4.1.4.1.7.3.2 | Cleanse and populate data post cut |  | 5d | 2023-10-09 A | 2023-10-13 A | 715 | 100% | 2023-10-09 | 2023-10-13 | 5d | 2023-10-09 | 2023-10-13 |  |  | SI Test |  | SIT | 5.0 | Cesar Lopes | Systems Integration Testing (SIT) | Complete | COMPLETE |  |  |  |  |
| 717 | 1.4.1.4.1.7.3.3 | Transmit data sets to PPs |  | 2d | 2023-10-16 A | 2023-10-17 A | 716 | 100% | 2023-10-16 | 2023-10-17 | 2d | 2023-10-16 | 2023-10-17 |  |  | SI Test |  | SIT | 5.0 | Cesar Lopes | Systems Integration Testing (SIT) | Complete | COMPLETE |  |  |  |  |
| 718 | 1.4.1.4.1.7.3.4 | PP - Load test data to test environments |  | 8d | 2023-10-18 A | 2023-10-27 A | 717 | 100% | 2023-10-18 | 2023-10-27 | 8d | 2023-10-18 | 2023-10-27 |  |  | PP |  | SIT | 5.0 | Cesar Lopes | Systems Integration Testing (SIT) | Complete | COMPLETE |  |  |  |  |
| 719 | 1.4.1.4.1.7.3.5 | PP Check data integrity on test environment |  | 15d | 2023-10-30 A | 2023-11-17 A | 718 | 100% | 2023-10-30 | 2023-11-17 | 5d | 2023-10-30 | 2023-11-03 |  |  | PP |  | SIT | 5.0 | Cesar Lopes | Systems Integration Testing (SIT) | Complete | COMPLETE |  |  |  |  |
| 720 | 1.4.1.4.1.7.3.6 | PP submit self-declaration to Programme to confirm loading & verification of test data | milestone | 0d | 2023-11-17 A | 2023-11-17 A | 719FF | 100% | 2023-11-17 | 2023-11-17 | 0d | 2023-11-03 | 2023-11-03 |  |  | PP | SI Test | SIT | 5.0 | Cesar Lopes | Systems Integration Testing (SIT) | Complete | COMPLETE |  |  |  |  |
| 721 | 1.4.1.4.1.7.3.7 | Test Data (SIT A) Interval 3 Complete | milestone | 0d | 2023-11-17 A | 2023-11-17 A | 720 | 100% | 2023-11-17 | 2023-11-17 | 0d |  |  |  |  | SI Test | PP | SIT | 5.13 | Cesar Lopes | Systems Integration Testing (SIT) | Complete | COMPLETE | MHHS-ART148/169 | T3-TE-0075 | SITAG | T3 |
| 722 | 1.4.1.4.1.7.4 | **Other Preparation** |  | 25d | 2023-10-16 A | 2023-11-17 A |  | 100% | 2023-10-16 | 2023-11-17 | 60d | 2023-07-17 | 2023-10-06 |  |  | N/A | N/A | SIT | 5.0 | N/A | Systems Integration Testing (SIT) |  |  |  |  |  |  |
| 723 | 1.4.1.4.1.7.4.1 | Onboarding of Test Participants to Test Management Tool (Azure DevOps) |  | 25d | 2023-10-16 A | 2023-11-17 A |  | 100% | 2023-10-16 | 2023-11-17 | 60d | 2023-07-17 | 2023-10-06 | start no earlier than 2023-10-16 |  | SI Test | PP | SIT | 5.0 | Simon Berry | Systems Integration Testing (SIT) | Complete | COMPLETE |  |  |  |  |
| 724 | 1.4.1.4.1.7.4.2 | Test Management Tool onboarding |  | 25d | 2023-10-16 A | 2023-11-17 A |  | 100% | 2023-10-16 | 2023-11-17 | 60d | 2023-07-17 | 2023-10-06 | start no earlier than 2023-10-16 |  | PP | SI Test | SIT | 5.0 | Simon Berry | Systems Integration Testing (SIT) | Complete | COMPLETE |  |  |  |  |
| 725 | 1.4.1.4.1.7.5 | **SIT Component Integration Test Readiness Report** |  | 25d | 2023-10-16 A | 2023-11-17 A |  | 100% | 2023-10-16 | 2023-11-17 | 25d | 2023-10-16 | 2023-11-17 |  |  | N/A | N/A | SIT | 5.0 | N/A | Systems Integration Testing (SIT) |  |  |  |  |  |  |
| 726 | 1.4.1.4.1.7.5.1 | PP submit Test Readiness Report to Programme for assurance | milestone | 0d | 2023-11-03 A | 2023-11-03 A | 610 | 100% | 2023-11-03 | 2023-11-03 | 0d | 2023-11-03 | 2023-11-03 |  |  | PP | SI Test | SIT | 5.0 |  | Systems Integration Testing (SIT) | Complete | COMPLETE |  |  |  |  |
| 727 | 1.4.1.4.1.7.5.2 | SI assure Test Participants' Test Readiness Reports |  | 5d | 2023-11-06 A | 2023-11-10 A | 726FF+5d | 100% | 2023-11-06 | 2023-11-10 | 5d | 2023-11-06 | 2023-11-10 |  |  | SI Test | PP,IPA | SIT | 5.0 |  | Systems Integration Testing (SIT) | Complete | COMPLETE |  |  |  |  |
| 728 | 1.4.1.4.1.7.5.3 | SI develop Overarching SIT Component Integration Test Readiness Report |  | 20d | 2023-10-16 A | 2023-11-10 A | 727FF | 100% | 2023-10-16 | 2023-11-10 | 20d | 2023-10-16 | 2023-11-10 |  |  | SI Test |  | SIT | 5.0 |  | Systems Integration Testing (SIT) | Complete | COMPLETE |  |  |  |  |
| 729 | 1.4.1.4.1.7.5.4 | Artefact review (via TMAG) and updates |  | 5d | 2023-11-13 A | 2023-11-17 A | 728 | 100% | 2023-11-13 | 2023-11-17 | 5d | 2023-11-13 | 2023-11-17 |  |  | SI Test | PP,IPA | SIT | 5.0 |  | Systems Integration Testing (SIT) | Complete | COMPLETE |  |  |  |  |
| 730 | 1.4.1.4.1.7.6 | SIT Component Integration Testing 3 Preparation Complete (incl. approval of SI SIT Component Integration Test Readiness Report) | milestone | 0d | 2023-11-20 A | 2023-11-20 A | 729FS+1d, 703, 707, 726, 724, 721, 321 | 100% | 2023-11-20 | 2023-11-20 | 0d | 2023-11-20 | 2023-11-20 |  |  | SI Test | PP,IPA | SIT | 5.12 |  | Systems Integration Testing (SIT) | Complete | COMPLETE | MHHS-ART071 | T2-TE-0350 | SITAG | T2 |
| 731 | 1.4.1.4.1.8 | **CIT Interval 4 Preparation** |  | 36d | 2023-10-16 A | 2023-12-04 A |  | 100% | 2023-10-16 | 2023-12-04 | 36d | 2022-11-16 | 2023-12-04 |  | -0 | N/A | N/A | SIT | 5.0 | N/A | Systems Integration Testing (SIT) |  |  |  |  |  |  |
| 732 | 1.4.1.4.1.8.1 | **PIT Test Completion Report (incl. evidence)** |  | 21d | 2023-10-27 A | 2023-11-24 A |  | 100% | 2023-10-27 | 2023-11-24 | 21d | 2023-10-27 | 2023-11-24 |  |  | N/A | N/A | SIT | 5.0 | N/A | Systems Integration Testing (SIT) |  |  |  |  |  |  |
| 733 | 1.4.1.4.1.8.1.1 | Submit draft PIT Test Completion Report (incl. evidence) and submit to Programme for assurance |  | 1d | 2023-10-27 A | 2023-10-27 A |  | 100% | 2023-10-27 | 2023-10-27 | 1d | 2023-10-27 | 2023-10-27 | must start on 2023-10-27 |  | PP | SI Test | SIT | 5.0 |  | Systems Integration Testing (SIT) | Complete | COMPLETE |  |  |  |  |
| 734 | 1.4.1.4.1.8.1.2 | Finalise PIT Test Completion Report (incl. evidence) |  | 15d | 2023-10-30 A | 2023-11-17 A | 733 | 100% | 2023-10-30 | 2023-11-17 | 15d | 2023-10-30 | 2023-11-17 |  |  | PP | SI Test | SIT | 5.0 |  | Systems Integration Testing (SIT) | Complete | COMPLETE |  |  |  |  |
| 735 | 1.4.1.4.1.8.1.3 | PP PIT Completion Report (excl. Migration/Reverse Migration) submitted to Programme for assurance CIT Interval 4 | milestone | 0d | 2023-11-17 A | 2023-11-17 A | 734, 79, 95 | 100% | 2023-11-17 | 2023-11-17 | 0d | 2023-11-17 | 2023-11-17 |  |  | PP | SI Test | SIT | 5.13 |  | Systems Integration Testing (SIT) | Complete | COMPLETE |  | T3-DB-0019 | SITAG | T3 |
| 736 | 1.4.1.4.1.8.1.4 | PP Final PIT Completion Reports assured by SI |  | 5d | 2023-11-20 A | 2023-11-24 A | 735 | 100% | 2023-11-20 | 2023-11-24 | 5d | 2023-11-20 | 2023-11-24 |  |  | SI Test | PP | SIT | 5.0 |  | Systems Integration Testing (SIT) | Complete | COMPLETE |  |  |  |  |
| 737 | 1.4.1.4.1.8.2 | **Environments (SIT A)** |  | 25d | 2023-10-23 A | 2023-11-24 A |  | 100% | 2023-10-23 | 2023-11-24 | 25d | 2022-11-16 | 2023-11-24 |  | -0 | N/A | N/A | SIT | 5.0 | N/A | Systems Integration Testing (SIT) |  |  |  |  |  |  |
| 738 | 1.4.1.4.1.8.2.1 | Programme Participants Ready to Start Connectivity Proving | milestone | 0d | 2023-10-23 A | 2023-10-23 A |  | 100% | 2023-10-23 | 2023-10-23 | 0d |  |  | start no earlier than 2023-10-23 |  | PP |  | SIT | 5.10 | Simon Berry | Systems Integration Testing (SIT) | Complete | COMPLETE |  |  |  |  |
| 739 | 1.4.1.4.1.8.2.2 | SIT Participants' SIT A environments ready to start connectivity proving CIT Interval 4 | milestone | 0d | 2023-10-23 A | 2023-10-23 A | 738 | 100% | 2023-10-23 | 2023-10-23 | 0d | 2023-10-20 | 2023-10-20 |  |  | PP | PP,IPA | SIT | 5.10 | Simon Berry | Systems Integration Testing (SIT) | Complete | COMPLETE | MHHS-ART139 | T3-TE-0022 | SITAG | T3 |
| 740 | 1.4.1.4.1.8.2.3 | Internal Connectivity Proving Phase |  | 10d | 2023-10-23 A | 2023-11-03 A | 739 | 100% | 2023-10-23 | 2023-11-03 | 10d |  |  |  |  | PP |  | SIT | 5.10 | Simon Berry | Systems Integration Testing (SIT) | Complete | COMPLETE |  |  |  |  |
| 741 | 1.4.1.4.1.8.2.4 | Internal Connectivity Proving Phase Complete | milestone | 0d | 2023-11-03 A | 2023-11-03 A | 740 | 100% | 2023-11-03 | 2023-11-03 | 0d |  |  |  |  | PP |  | SIT | 5.10 | Simon Berry | Systems Integration Testing (SIT) | Complete | COMPLETE |  |  |  |  |
| 742 | 1.4.1.4.1.8.2.5 | DIP Onboarding Activity (1. PKI Officers and Certificates, 2. Set-up Validation, 3. End Point Creation, 4. Controlled Smoke Test ) |  | 10d | 2023-11-13 A | 2023-11-24 A | 741FS+5d | 100% | 2023-11-13 | 2023-11-24 | 10d |  |  |  |  | PP |  | SIT | 5.10 | Simon Berry | Systems Integration Testing (SIT) | Complete | COMPLETE |  |  |  |  |
| 743 | 1.4.1.4.1.8.2.6 | DIP Onboarding Complete | milestone | 0d | 2023-11-24 A | 2023-11-24 A | 742 | 100% | 2023-11-24 | 2023-11-24 | 0d |  |  |  |  | PP |  | SIT | 5.10 | Simon Berry | Systems Integration Testing (SIT) | Complete | COMPLETE |  |  |  |  |
| 744 | 1.4.1.4.1.8.2.7 | PPs register PKI Officers and Request PKI Certificates Complete - Interval 4 | milestone | 0d | 2023-11-24 A | 2023-11-24 A | 743 | 100% | 2023-11-24 | 2023-11-24 | 0d |  |  |  |  | PP | DIP Provider | SIT | 5.16 | Simon Berry | Systems Integration Testing (SIT) | Complete | COMPLETE |  | T3-TE-0100 | SITAG | T3 |
| 745 | 1.4.1.4.1.8.2.8 | PP Code Deployment | milestone | 0d | 2023-11-17 A | 2023-11-17 A |  | 100% | 2023-11-17 | 2023-11-17 | 0d |  |  | start no earlier than 2023-11-17 |  | PP |  | SIT | 5.10 | Simon Berry | Systems Integration Testing (SIT) | Complete | COMPLETE |  |  |  |  |

Notes:
- 721: Action: 28/7: CH: Needs to be set-up as a reporting milestone. 31/7: Check with Cesar if has been approved so can be baselined

| ID | WBS | Task | Type | Duration | Start | Finish | Predecessors | Complete | Baseline start | Baseline finish | Baseline duration | Baseline 1 start | Baseline 1 finish | Constraint | Baseline cost | Responsible | Involved | Text9 | Update Version | MHHS Resource Name | MHHS Programme Phase | Sched Status | RAG | Artefact ID | Milestone ID | Text29 | Tier |
| --- | --- | --- | --- | --- | --- | --- | --- | --- | --- | --- | --- | --- | --- | --- | --- | --- | --- | --- | --- | --- | --- | --- | --- | --- | --- | --- | --- |
| 746 | 1.4.1.4.1.8.3 | **Test Data (SIT A) Interval 4** |  | 30d | 2023-10-23 A | 2023-12-01 A |  | 100% | 2023-10-23 | 2023-12-01 | 25d | 2023-10-16 | 2023-11-17 |  |  | N/A | N/A | SIT | 5.0 | N/A | Systems Integration Testing (SIT) |  |  |  |  |  |  |
| 747 | 1.4.1.4.1.8.3.1 | Run data allocation |  | 5d | 2023-10-23 A | 2023-10-27 A | 716FS+5d | 100% | 2023-10-23 | 2023-10-27 | 5d | 2023-10-16 | 2023-10-20 |  |  | SI Test |  | SIT | 5.0 | Cesar Lopes | Systems Integration Testing (SIT) | Complete | COMPLETE |  |  |  |  |
| 748 | 1.4.1.4.1.8.3.2 | Cleanse and populate data post cut |  | 2d | 2023-10-30 A | 2023-10-31 A | 747 | 100% | 2023-10-30 | 2023-10-31 | 5d | 2023-10-23 | 2023-10-27 |  |  | SI Test |  | SIT | 5.0 | Cesar Lopes | Systems Integration Testing (SIT) | Complete | COMPLETE |  |  |  |  |
| 749 | 1.4.1.4.1.8.3.3 | Transmit data sets to PPs |  | 5d | 2023-11-01 A | 2023-11-07 A | 748 | 100% | 2023-11-01 | 2023-11-07 | 2d | 2023-10-30 | 2023-10-31 |  |  | SI Test |  | SIT | 5.0 | Cesar Lopes | Systems Integration Testing (SIT) | Complete | COMPLETE |  |  |  |  |
| 750 | 1.4.1.4.1.8.3.4 | PP - Load test data to test environments |  | 5d | 2023-11-08 A | 2023-11-14 A | 749 | 100% | 2023-11-08 | 2023-11-14 | 8d | 2023-11-01 | 2023-11-10 |  |  | PP |  | SIT | 5.0 | Cesar Lopes | Systems Integration Testing (SIT) | Complete | COMPLETE |  |  |  |  |
| 751 | 1.4.1.4.1.8.3.5 | PP Check data integrity on test environment |  | 13d | 2023-11-15 A | 2023-12-01 A | 750 | 100% | 2023-11-15 | 2023-12-01 | 5d | 2023-11-13 | 2023-11-17 |  |  | PP |  | SIT | 5.0 | Richard Puddephatt | Systems Integration Testing (SIT) | Complete | COMPLETE |  |  |  |  |
| 752 | 1.4.1.4.1.8.3.6 | PP submit self-declaration to Programme to confirm loading & verification of test data | milestone | 0d | 2023-12-01 A | 2023-12-01 A | 751FF | 100% | 2023-12-01 | 2023-12-01 | 0d | 2023-11-17 | 2023-11-17 |  |  | PP | SI Test | SIT | 5.0 | Richard Puddephatt | Systems Integration Testing (SIT) | Complete | COMPLETE |  |  |  |  |
| 753 | 1.4.1.4.1.8.3.7 | Test Data (SIT A) Interval 4 Complete | milestone | 0d | 2023-12-01 A | 2023-12-01 A | 752 | 100% | 2023-12-01 | 2023-12-01 | 0d |  |  |  |  | SI Test | PP | SIT | 5.13 | Richard Puddephatt | Systems Integration Testing (SIT) | Complete | COMPLETE | MHHS-ART148/169 | T3-TE-0076 | SITAG | T3 |
| 754 | 1.4.1.4.1.8.4 | **Other Preparation** |  | 25d | 2023-10-30 A | 2023-12-01 A |  | 100% | 2023-10-30 | 2023-12-01 | 25d | 2023-07-31 | 2023-10-20 |  | -0 | N/A | N/A | SIT | 5.0 | N/A | Systems Integration Testing (SIT) |  |  |  |  |  |  |
| 755 | 1.4.1.4.1.8.4.1 | Onboarding of Test Participants to Test Management Tool (Azure DevOps) |  | 25d | 2023-10-30 A | 2023-12-01 A |  | 100% | 2023-10-30 | 2023-12-01 | 25d | 2023-07-31 | 2023-10-20 | start no earlier than 2023-10-30 |  | SI Test | PP | SIT | 5.0 | Simon Berry | Systems Integration Testing (SIT) | Complete | COMPLETE |  |  |  |  |
| 756 | 1.4.1.4.1.8.4.2 | Test Management Tool onboarding |  | 25d | 2023-10-30 A | 2023-12-01 A |  | 100% | 2023-10-30 | 2023-12-01 | 25d | 2023-07-31 | 2023-10-20 | start no earlier than 2023-10-30 |  | PP | SI Test | SIT | 5.0 | Simon Berry | Systems Integration Testing (SIT) | Complete | COMPLETE |  |  |  |  |
| 757 | 1.4.1.4.1.8.5 | **SIT Component Integration Test Readiness Report** |  | 27d | 2023-10-16 A | 2023-11-21 A |  | 100% | 2023-10-16 | 2023-11-21 | 25d | 2023-10-30 | 2023-12-01 |  |  | N/A | N/A | SIT | 5.0 | N/A | Systems Integration Testing (SIT) |  |  |  |  |  |  |
| 758 | 1.4.1.4.1.8.5.1 | PP submit Test Readiness Report to Programme for assurance | milestone | 0d | 2023-11-03 A | 2023-11-03 A | 610 | 100% | 2023-11-03 | 2023-11-03 | 0d | 2023-11-17 | 2023-11-17 |  |  | PP | SI Test | SIT | 5.0 |  | Systems Integration Testing (SIT) | Complete | COMPLETE |  |  |  |  |
| 759 | 1.4.1.4.1.8.5.2 | SI assure Test Participants' Test Readiness Reports |  | 5d | 2023-11-06 A | 2023-11-10 A | 758FF+5d | 100% | 2023-11-06 | 2023-11-10 | 5d | 2023-11-20 | 2023-11-24 |  |  | SI Test | PP,IPA | SIT | 5.0 |  | Systems Integration Testing (SIT) | Complete | COMPLETE |  |  |  |  |
| 760 | 1.4.1.4.1.8.5.3 | SI develop Overarching SIT Component Integration Test Readiness Report |  | 20d | 2023-10-16 A | 2023-11-10 A | 759FF | 100% | 2023-10-16 | 2023-11-10 | 20d | 2023-10-30 | 2023-11-24 |  |  | SI Test |  | SIT | 5.0 |  | Systems Integration Testing (SIT) | Complete | COMPLETE |  |  |  |  |
| 761 | 1.4.1.4.1.8.5.4 | Artefact review (via SITAG) and updates |  | 7d | 2023-11-13 A | 2023-11-21 A | 760 | 100% | 2023-11-13 | 2023-11-21 | 5d | 2023-11-27 | 2023-12-01 |  |  | SI Test | PP,IPA | SIT | 5.0 |  | Systems Integration Testing (SIT) | Complete | COMPLETE |  |  |  |  |
| 762 | 1.4.1.4.1.8.6 | SIT Component Integration Testing 4 Preparation Complete (incl. approval of SI SIT Component Integration Test Readiness Report) | milestone | 0d | 2023-12-04 A | 2023-12-04 A | 761FS+2d, 735, 739, 758, 753, 338FS+1d | 100% | 2023-12-04 | 2023-12-04 | 0d | 2023-12-04 | 2023-12-04 |  |  | SI Test | PP,IPA | SIT | 5.13 |  | Systems Integration Testing (SIT) | Complete | COMPLETE | MHHS-ART071 | T2-TE-0400 | SITAG | T2 |
| 763 | 1.4.1.4.1.9 | **CIT Interval 5 Preparation** |  | 53d | 2023-11-01 A | 2024-01-12 A |  | 100% | 2023-11-01 | 2024-01-12 | 55d | 2022-11-16 | 2024-01-08 |  | -0 | N/A | N/A | SIT | 5.0 | N/A | Systems Integration Testing (SIT) |  |  |  |  |  |  |
| 764 | 1.4.1.4.1.9.1 | **PIT Test Completion Report (incl. evidence)** |  | 21d | 2023-11-17 A | 2023-12-15 A |  | 100% | 2023-11-17 | 2023-12-15 | 21d | 2023-11-17 | 2023-12-15 |  |  | N/A | N/A | SIT | 5.0 | N/A | Systems Integration Testing (SIT) |  |  |  |  |  |  |
| 765 | 1.4.1.4.1.9.1.1 | Submit draft PIT Test Completion Report (incl. evidence) and submit to Programme for assurance |  | 1d | 2023-11-17 A | 2023-11-17 A |  | 100% | 2023-11-17 | 2023-11-17 | 1d | 2023-11-17 | 2023-11-17 | must start on 2023-11-17 |  | PP | SI Test | SIT | 5.0 | Lee Cox | Systems Integration Testing (SIT) | Complete | COMPLETE |  |  |  |  |
| 766 | 1.4.1.4.1.9.1.2 | Finalise PIT Test Completion Report (incl. evidence) |  | 15d | 2023-11-20 A | 2023-12-08 A | 765 | 100% | 2023-11-20 | 2023-12-08 | 15d | 2023-11-20 | 2023-12-08 |  |  | PP | SI Test | SIT | 5.0 | Lee Cox | Systems Integration Testing (SIT) | Complete | COMPLETE |  |  |  |  |
| 767 | 1.4.1.4.1.9.1.3 | PP PIT Completion Report (excl. Migration/Reverse Migration) submitted to Programme for assurance CIT Interval 5 | milestone | 0d | 2023-12-08 A | 2023-12-08 A | 766, 79, 95 | 100% | 2023-12-08 | 2023-12-08 | 0d | 2023-12-08 | 2023-12-08 |  |  | PP | SI Test | SIT | 5.14 | Lee Cox | Systems Integration Testing (SIT) | Complete | COMPLETE |  | T3-DB-0021 | SITAG | T3 |
| 768 | 1.4.1.4.1.9.1.4 | PP Final PIT Completion Reports assured by SI |  | 5d | 2023-12-11 A | 2023-12-15 A | 767 | 100% | 2023-12-11 | 2023-12-15 | 5d | 2023-12-11 | 2023-12-15 |  |  | SI Test | PP | SIT | 5.0 | Lee Cox | Systems Integration Testing (SIT) | Complete | COMPLETE |  |  |  |  |
| 769 | 1.4.1.4.1.9.2 | **Environments (SIT A)** |  | 21d | 2023-11-10 A | 2023-12-08 A |  | 100% | 2023-11-10 | 2023-12-08 | 21d | 2022-11-16 | 2023-12-15 |  | -0 | N/A | N/A | SIT | 5.0 | N/A | Systems Integration Testing (SIT) |  |  |  |  |  |  |
| 770 | 1.4.1.4.1.9.2.1 | Programme Participants Ready to Start Connectivity Proving | milestone | 0d | 2023-11-10 A | 2023-11-10 A |  | 100% | 2023-11-10 | 2023-11-10 | 0d |  |  | start no earlier than 2023-11-10 |  | PP |  | SIT | 5.10 | Simon Berry | Systems Integration Testing (SIT) | Complete | COMPLETE |  |  |  |  |
| 771 | 1.4.1.4.1.9.2.2 | SIT Participants' SIT A environments ready to start connectivity proving CIT Interval 5 | milestone | 0d | 2023-11-10 A | 2023-11-10 A | 770 | 100% | 2023-11-10 | 2023-11-10 | 0d | 2023-11-10 | 2023-11-10 |  |  | PP | PP,IPA | SIT | 5.6 | Simon Berry | Systems Integration Testing (SIT) | Complete | COMPLETE | MHHS-ART139 | T3-TE-0023 | SITAG | T3 |
| 772 | 1.4.1.4.1.9.2.3 | Internal Connectivity Proving Phase |  | 10d | 2023-11-13 A | 2023-11-24 A | 770FS+1d | 100% | 2023-11-13 | 2023-11-24 | 10d |  |  |  |  | PP |  | SIT | 5.10 | Simon Berry | Systems Integration Testing (SIT) | Complete | COMPLETE |  |  |  |  |
| 773 | 1.4.1.4.1.9.2.4 | Internal Connectivity Proving Phase Complete | milestone | 0d | 2023-11-24 A | 2023-11-24 A | 772 | 100% | 2023-11-24 | 2023-11-24 | 0d |  |  |  |  | PP |  | SIT | 5.10 | Simon Berry | Systems Integration Testing (SIT) | Complete | COMPLETE |  |  |  |  |
| 774 | 1.4.1.4.1.9.2.5 | DIP Onboarding Activity (1. PKI Officers and Certificates, 2. Set-up Validation, 3. End Point Creation, 4. Controlled Smoke Test ) |  | 10d | 2023-11-27 A | 2023-12-08 A | 773 | 100% | 2023-11-27 | 2023-12-08 | 10d |  |  |  |  | PP |  | SIT | 5.10 | Simon Berry | Systems Integration Testing (SIT) | Complete | COMPLETE |  |  |  |  |
| 775 | 1.4.1.4.1.9.2.6 | DIP Onboarding Complete | milestone | 0d | 2023-12-08 A | 2023-12-08 A | 774 | 100% | 2023-12-08 | 2023-12-08 | 0d |  |  |  |  | PP |  | SIT | 5.10 | Simon Berry | Systems Integration Testing (SIT) | Complete | COMPLETE |  |  |  |  |
| 776 | 1.4.1.4.1.9.2.7 | PPs register PKI Officers and Request PKI Certificates Complete - Interval 5 | milestone | 0d | 2023-12-08 A | 2023-12-08 A | 775 | 100% | 2023-12-08 | 2023-12-08 | 0d | 2023-11-06 | 2023-11-10 |  |  | PP | DIP Provider | SIT | 5.17 | Simon Berry | Systems Integration Testing (SIT) | Complete | COMPLETE |  | T3-TE-0101 | SITAG | T3 |
| 777 | 1.4.1.4.1.9.2.8 | PP Code Deployment | milestone | 0d | 2023-12-08 A | 2023-12-08 A | 776 | 100% | 2023-12-08 | 2023-12-08 | 0d |  |  | start no earlier than 2023-10-20 |  | PP |  | SIT | 5.10 | Simon Berry | Systems Integration Testing (SIT) | Complete | COMPLETE |  |  |  |  |

| ID | WBS | Task | Type | Duration | Start | Finish | Predecessors | Complete | Baseline start | Baseline finish | Baseline duration | Baseline 1 start | Baseline 1 finish | Constraint | Baseline cost | Responsible | Involved | Text9 | Update Version | MHHS Resource Name | MHHS Programme Phase | Sched Status | RAG | Artefact ID | Milestone ID | Text29 | Tier |
| --- | --- | --- | --- | --- | --- | --- | --- | --- | --- | --- | --- | --- | --- | --- | --- | --- | --- | --- | --- | --- | --- | --- | --- | --- | --- | --- | --- |
| 778 | 1.4.1.4.1.9.3 | **Test Data (SIT A) Interval 5** |  | 33d | 2023-11-01 A | 2023-12-15 A |  | 100% | 2023-11-01 | 2023-12-15 | 30d | 2023-10-30 | 2023-12-08 |  |  | N/A | N/A | SIT | 5.0 | N/A | Systems Integration Testing (SIT) |  |  |  |  |  |  |
| 779 | 1.4.1.4.1.9.3.1 | Run data allocation |  | 5d | 2023-11-01 A | 2023-11-07 A | 749SS | 100% | 2023-11-01 | 2023-11-07 | 10d | 2023-10-30 | 2023-11-10 |  |  | SI Test |  | SIT | 5.0 | Cesar Lopes | Systems Integration Testing (SIT) | Complete | COMPLETE |  |  |  |  |
| 780 | 1.4.1.4.1.9.3.2 | Cleanse and populate data post cut |  | 8d | 2023-11-08 A | 2023-11-17 A | 779 | 100% | 2023-11-08 | 2023-11-17 | 5d | 2023-11-13 | 2023-11-17 |  |  | SI Test |  | SIT | 5.0 | Cesar Lopes | Systems Integration Testing (SIT) | Complete | COMPLETE |  |  |  |  |
| 781 | 1.4.1.4.1.9.3.3 | Transmit data sets to PPs |  | 2d | 2023-11-20 A | 2023-11-21 A | 780 | 100% | 2023-11-20 | 2023-11-21 | 2d | 2023-11-20 | 2023-11-21 |  |  | SI Test |  | SIT | 5.0 | Cesar Lopes | Systems Integration Testing (SIT) | Complete | COMPLETE |  |  |  |  |
| 782 | 1.4.1.4.1.9.3.4 | PP - Load test data to test environments |  | 8d | 2023-11-22 A | 2023-12-01 A | 781 | 100% | 2023-11-22 | 2023-12-01 | 8d | 2023-11-22 | 2023-12-01 |  |  | PP |  | SIT | 5.0 | Richard Puddephatt | Systems Integration Testing (SIT) | Complete | COMPLETE |  |  |  |  |
| 783 | 1.4.1.4.1.9.3.5 | PP Check data integrity on test environment |  | 10d | 2023-12-04 A | 2023-12-15 A | 782 | 100% | 2023-12-04 | 2023-12-15 | 5d | 2023-12-04 | 2023-12-08 |  |  | PP |  | SIT | 5.0 | Richard Puddephatt | Systems Integration Testing (SIT) | Complete | COMPLETE |  |  |  |  |
| 784 | 1.4.1.4.1.9.3.6 | PP submit self-declaration to Programme to confirm loading & verification of test data | milestone | 0d | 2023-12-15 A | 2023-12-15 A | 783FF | 100% | 2023-12-15 | 2023-12-15 | 0d | 2023-12-08 | 2023-12-08 |  |  | PP | SI Test | SIT | 5.0 | Richard Puddephatt | Systems Integration Testing (SIT) | Complete | COMPLETE |  |  |  |  |
| 785 | 1.4.1.4.1.9.3.7 | Test Data (SIT A) Interval 5 Complete | milestone | 0d | 2023-12-15 A | 2023-12-15 A | 784 | 100% | 2023-12-15 | 2023-12-15 | 0d |  |  |  |  | SI Test | PP | SIT | 5.14 | Richard Puddephatt | Systems Integration Testing (SIT) | Complete | COMPLETE | MHHS-ART148/169 | T3-TE-0077 | SITAG | T3 |
| 786 | 1.4.1.4.1.9.4 | **Other Preparation** |  | 40d | 2023-11-20 A | 2024-01-12 A |  | 100% | 2023-11-20 | 2024-01-12 | 40d | 2023-08-21 | 2023-11-10 |  | -0 | N/A | N/A | SIT | 5.0 | N/A | Systems Integration Testing (SIT) |  |  |  |  |  |  |
| 787 | 1.4.1.4.1.9.4.1 | Onboarding of Test Participants to Test Management Tool (Azure DevOps) |  | 40d | 2023-11-20 A | 2024-01-12 A |  | 100% | 2023-11-20 | 2024-01-12 | 40d | 2023-08-21 | 2023-11-10 | start no earlier than 2023-11-20 |  | SI Test | PP | SIT | 5.0 | Simon Berry | Systems Integration Testing (SIT) | Complete | COMPLETE |  |  |  |  |
| 788 | 1.4.1.4.1.9.4.2 | Test Management Tool onboarding |  | 36d | 2023-11-20 A | 2024-01-08 A |  | 100% | 2023-11-20 | 2024-01-08 | 36d | 2023-08-21 | 2023-11-10 | start no earlier than 2023-11-20 |  | PP | SI Test | SIT | 5.0 | Simon Berry | Systems Integration Testing (SIT) | Complete | COMPLETE |  |  |  |  |
| 789 | 1.4.1.4.1.9.5 | **SIT Component Integration Test Readiness Report** |  | 35d | 2023-11-20 A | 2024-01-05 A |  | 100% | 2023-11-20 | 2024-01-05 | 35d | 2023-11-20 | 2024-01-05 |  |  | N/A | N/A | SIT | 5.0 | N/A | Systems Integration Testing (SIT) |  |  |  |  |  |  |
| 790 | 1.4.1.4.1.9.5.1 | PP submit Test Readiness Report to Programme for assurance | milestone | 0d | 2023-12-08 A | 2023-12-08 A | 614 | 100% | 2023-12-08 | 2023-12-08 | 0d | 2023-12-08 | 2023-12-08 |  |  | PP | SI Test | SIT | 5.0 | Lee Cox | Systems Integration Testing (SIT) | Complete | COMPLETE |  |  |  |  |
| 791 | 1.4.1.4.1.9.5.2 | SI assure Test Participants' Test Readiness Reports |  | 5d | 2023-12-11 A | 2023-12-15 A | 790FF+5d | 100% | 2023-12-11 | 2023-12-15 | 5d | 2023-12-11 | 2023-12-15 |  |  | SI Test | PP,IPA | SIT | 5.0 | Lee Cox | Systems Integration Testing (SIT) | Complete | COMPLETE |  |  |  |  |
| 792 | 1.4.1.4.1.9.5.3 | SI develop Overarching SIT Component Integration Test Readiness Report |  | 20d | 2023-11-20 A | 2023-12-15 A | 791FF | 100% | 2023-11-20 | 2023-12-15 | 20d | 2023-11-20 | 2023-12-15 |  |  | SI Test |  | SIT | 5.0 | Lee Cox | Systems Integration Testing (SIT) | Complete | COMPLETE |  |  |  |  |
| 793 | 1.4.1.4.1.9.5.4 | Artefact review (via SITAG) and updates |  | 15d | 2023-12-18 A | 2024-01-05 A | 792 | 100% | 2023-12-18 | 2024-01-05 | 15d | 2023-12-18 | 2024-01-05 |  |  | SI Test | PP,IPA | SIT | 5.0 | Lee Cox | Systems Integration Testing (SIT) | Complete | COMPLETE |  |  |  |  |
| 794 | 1.4.1.4.1.9.6 | SIT Component Integration Testing 5 Preparation Complete (incl. approval of SI SIT Component Integration Test Readiness Report) | milestone | 0d | 2024-01-08 A | 2024-01-08 A | 793FS+1d, 767, 771, 788, 790, 785, 440, 423 | 100% | 2024-01-08 | 2024-01-08 | 0d | 2024-01-08 | 2024-01-08 |  |  | SI Test | PP,IPA | SIT | 5.15 |  | Systems Integration Testing (SIT) | Complete | COMPLETE | MHHS-ART071 | T2-TE-0450 | SITAG | T2 |
| 795 | 1.4.1.4.1.10 | **CIT Interval 6 Preparation** |  | 45d | 2023-11-20 A | 2024-01-19 A |  | 100% | 2023-11-20 | 2024-01-19 | 46d | 2022-11-16 | 2024-01-22 |  | -0 | N/A | N/A | SIT | 5.0 | N/A | Systems Integration Testing (SIT) |  |  |  |  |  |  |
| 796 | 1.4.1.4.1.10.1 | **PIT Test Completion Report (incl. evidence)** |  | 31d | 2023-12-01 A | 2024-01-12 A |  | 100% | 2023-12-01 | 2024-01-12 | 31d | 2023-12-01 | 2024-01-12 |  |  | N/A | N/A | SIT | 5.0 | N/A | Systems Integration Testing (SIT) |  |  |  |  |  |  |
| 797 | 1.4.1.4.1.10.1.1 | Submit draft PIT Test Completion Report (incl. evidence) and submit to Programme for assurance |  | 1d | 2023-12-01 A | 2023-12-01 A |  | 100% | 2023-12-01 | 2023-12-01 | 1d | 2023-12-01 | 2023-12-01 | must start on 2023-12-01 |  | PP | SI Test | SIT | 5.0 |  | Systems Integration Testing (SIT) | Complete | COMPLETE |  |  |  |  |
| 798 | 1.4.1.4.1.10.1.2 | Finalise PIT Test Completion Report (incl. evidence) |  | 25d | 2023-12-04 A | 2024-01-05 A | 797 | 100% | 2023-12-04 | 2024-01-05 | 25d | 2023-12-04 | 2024-01-05 |  |  | PP | SI Test | SIT | 5.0 |  | Systems Integration Testing (SIT) | Complete | COMPLETE |  |  |  |  |
| 799 | 1.4.1.4.1.10.1.3 | PP PIT Completion Report (excl. Migration/Reverse Migration) submitted to Programme for assurance CIT Interval 6 | milestone | 0d | 2024-01-05 A | 2024-01-05 A | 798, 79, 95, 260, 265, 268 | 100% | 2024-01-05 | 2024-01-05 | 0d | 2024-01-05 | 2024-01-05 |  |  | PP | SI Test | SIT | 5.19 |  | Systems Integration Testing (SIT) | Complete | COMPLETE |  | T3-DB-0023 | SITAG | T3 |
| 800 | 1.4.1.4.1.10.1.4 | PP Final PIT Completion Reports assured by SI |  | 5d | 2024-01-08 A | 2024-01-12 A | 799 | 100% | 2024-01-08 | 2024-01-12 | 5d | 2024-01-08 | 2024-01-12 |  |  | SI Test | PP | SIT | 5.19 |  | Systems Integration Testing (SIT) | Complete | COMPLETE |  |  |  |  |
| 801 | 1.4.1.4.1.10.2 | **Environments (SIT A)** |  | 30d | 2023-11-24 A | 2024-01-05 A |  | 100% | 2023-11-24 | 2024-01-05 | 30d | 2022-11-16 | 2024-01-05 |  | -0 | N/A | N/A | SIT | 5.0 | N/A | Systems Integration Testing (SIT) |  |  |  |  |  |  |
| 802 | 1.4.1.4.1.10.2.1 | Programme Participants Ready to Start Connectivity Proving | milestone | 0d | 2023-11-24 A | 2023-11-24 A |  | 100% | 2023-11-24 | 2023-11-24 | 0d |  |  | start no earlier than 2023-11-24 |  | PP |  | SIT | 5.10 | Simon Berry | Systems Integration Testing (SIT) | Complete | COMPLETE |  |  |  |  |
| 803 | 1.4.1.4.1.10.2.2 | SIT Participants' SIT A environments ready to start connectivity proving CIT Interval 6 | milestone | 0d | 2023-11-24 A | 2023-11-24 A | 802 | 100% | 2023-11-24 | 2023-11-24 | 0d | 2023-11-24 | 2023-11-24 |  |  | PP | PP,IPA | SIT | 5.6 | Simon Berry | Systems Integration Testing (SIT) | Complete | COMPLETE | MHHS-ART139 | T3-TE-0024 | SITAG | T3 |
| 804 | 1.4.1.4.1.10.2.3 | Internal Connectivity Proving Phase |  | 10d | 2023-11-27 A | 2023-12-08 A | 803FS+1d | 100% | 2023-11-27 | 2023-12-08 | 10d |  |  |  |  | PP |  | SIT | 5.10 | Simon Berry | Systems Integration Testing (SIT) | Complete | COMPLETE |  |  |  |  |
| 805 | 1.4.1.4.1.10.2.4 | Internal Connectivity Proving Phase Complete | milestone | 0d | 2023-12-08 A | 2023-12-08 A | 804 | 100% | 2023-12-08 | 2023-12-08 | 0d |  |  |  |  | PP |  | SIT | 5.10 | Simon Berry | Systems Integration Testing (SIT) | Complete | COMPLETE |  |  |  |  |
| 806 | 1.4.1.4.1.10.2.5 | DIP Onboarding Activity (1. PKI Officers and Certificates, 2. Set-up Validation, 3. End Point Creation, 4. Controlled Smoke Test ) |  | 5d | 2023-12-04 A | 2023-12-08 A | 803FS+6d | 100% | 2023-12-04 | 2023-12-08 | 5d |  |  |  |  | PP |  | SIT | 5.10 | Simon Berry | Systems Integration Testing (SIT) | Complete | COMPLETE |  |  |  |  |
| 807 | 1.4.1.4.1.10.2.6 | DIP Onboarding Complete | milestone | 0d | 2023-12-08 A | 2023-12-08 A | 806 | 100% | 2023-12-08 | 2023-12-08 | 0d |  |  |  |  | PP |  | SIT | 5.10 | Simon Berry | Systems Integration Testing (SIT) | Complete | COMPLETE |  |  |  |  |
| 808 | 1.4.1.4.1.10.2.7 | PPs register PKI Officers and Request PKI Certificates Complete - Interval 6 | milestone | 0d | 2023-12-08 A | 2023-12-08 A | 807 | 100% | 2023-12-08 | 2023-12-08 | 0d | 2023-11-20 | 2023-11-24 | start no earlier than 2023-12-08 |  | PP | DIP Provider | SIT | 5.17 | Simon Berry | Systems Integration Testing (SIT) | Complete | COMPLETE |  | T3-TE-0102 | SITAG | T3 |
| 809 | 1.4.1.4.1.10.2.8 | PP Code Deployment | milestone | 0d | 2024-01-05 A | 2024-01-05 A |  | 100% | 2024-01-05 | 2024-01-05 | 0d |  |  | start no earlier than 2024-01-05 |  | PP |  | SIT | 5.10 | Simon Berry | Systems Integration Testing (SIT) | Complete | COMPLETE |  |  |  |  |

Notes:
- 785: Action: 28/7: CH: Needs to be set-up as a reporting milestone. 31/7: Check with Cesar if has been approved so can be baselined

| ID | WBS | Task | Type | Duration | Start | Finish | Predecessors | Complete | Remaining | Baseline start | Baseline finish | Baseline duration | Baseline 1 start | Baseline 1 finish | Total slack | Constraint | Baseline cost | Responsible | Involved | Text9 | Update Version | MHHS Resource Name | MHHS Programme Phase | Sched Status | RAG | Artefact ID | Milestone ID | Text29 | Tier |
| --- | --- | --- | --- | --- | --- | --- | --- | --- | --- | --- | --- | --- | --- | --- | --- | --- | --- | --- | --- | --- | --- | --- | --- | --- | --- | --- | --- | --- | --- |
| 810 | 1.4.1.4.1.10.3 | **Test Data (SIT A) Interval 6** |  | 25d | 2023-11-20 A | 2023-12-22 A |  | 100% |  | 2023-11-20 | 2023-12-22 | 25d | 2023-11-20 | 2023-12-22 |  |  |  | N/A | N/A | SIT | 5.0 | N/A | Systems Integration Testing (SIT) |  |  |  |  |  |  |
| 811 | 1.4.1.4.1.10.3.1 | Run data allocation |  | 10d | 2023-11-20 A | 2023-12-01 A | 781SS | 100% |  | 2023-11-20 | 2023-12-01 | 5d | 2023-11-20 | 2023-11-24 |  |  |  | SI Test |  | SIT | 5.0 | Richard Puddephatt | Systems Integration Testing (SIT) | Complete | COMPLETE |  |  |  |  |
| 812 | 1.4.1.4.1.10.3.2 | Cleanse and populate data post cut |  | 1d | 2023-12-04 A | 2023-12-04 A | 811 | 100% |  | 2023-12-04 | 2023-12-04 | 5d | 2023-11-27 | 2023-12-01 |  |  |  | SI Test |  | SIT | 5.0 | Richard Puddephatt | Systems Integration Testing (SIT) | Complete | COMPLETE |  |  |  |  |
| 813 | 1.4.1.4.1.10.3.3 | Transmit data sets to PPs |  | 1d | 2023-12-05 A | 2023-12-05 A | 812 | 100% |  | 2023-12-05 | 2023-12-05 | 2d | 2023-12-04 | 2023-12-05 |  |  |  | SI Test |  | SIT | 5.0 | Richard Puddephatt | Systems Integration Testing (SIT) | Complete | COMPLETE |  |  |  |  |
| 814 | 1.4.1.4.1.10.3.4 | PP - Load test data to test environments |  | 8d | 2023-12-06 A | 2023-12-15 A | 813 | 100% |  | 2023-12-06 | 2023-12-15 | 8d | 2023-12-06 | 2023-12-15 |  |  |  | PP |  | SIT | 5.0 | Richard Puddephatt | Systems Integration Testing (SIT) | Complete | COMPLETE |  |  |  |  |
| 815 | 1.4.1.4.1.10.3.5 | PP Check data integrity on test environment |  | 5d | 2023-12-18 A | 2023-12-22 A | 814 | 100% |  | 2023-12-18 | 2023-12-22 | 5d | 2023-12-18 | 2023-12-22 |  |  |  | PP |  | SIT | 5.0 | Richard Puddephatt | Systems Integration Testing (SIT) | Complete | COMPLETE |  |  |  |  |
| 816 | 1.4.1.4.1.10.3.6 | PP submit self-declaration to Programme to confirm loading & verification of test data | milestone | 0d | 2023-12-22 A | 2023-12-22 A | 815FF | 100% |  | 2023-12-22 | 2023-12-22 | 0d | 2023-12-22 | 2023-12-22 |  |  |  | PP | SI Test | SIT | 5.0 | Richard Puddephatt | Systems Integration Testing (SIT) | Complete | COMPLETE |  |  |  |  |
| 817 | 1.4.1.4.1.10.3.7 | Test Data (SIT A) Interval 6 Complete | milestone | 0d | 2023-12-22 A | 2023-12-22 A | 816 | 100% |  | 2023-12-22 | 2023-12-22 | 0d |  |  |  |  |  | SI Test | PP | SIT | 5.5 | Richard Puddephatt | Systems Integration Testing (SIT) | Complete | COMPLETE | MHHS-ART148/169 | T3-TE-0078 | SITAG | T3 |
| 818 | 1.4.1.4.1.10.4 | **Other Preparation** |  | 31d | 2023-12-04 A | 2024-01-15 A |  | 100% |  | 2023-12-04 | 2024-01-15 | 31d | 2023-09-04 | 2023-11-24 |  |  | -0 | N/A | N/A | SIT | 5.0 | N/A | Systems Integration Testing (SIT) |  |  |  |  |  |  |
| 819 | 1.4.1.4.1.10.4.1 | Onboarding of Test Participants to Test Management Tool (Azure DevOps) |  | 31d | 2023-12-04 A | 2024-01-15 A |  | 100% |  | 2023-12-04 | 2024-01-15 | 31d | 2023-09-04 | 2023-11-24 |  | start no earlier than 2023-12-04 |  | SI Test | PP | SIT | 5.0 | Simon Berry | Systems Integration Testing (SIT) | Complete | COMPLETE |  |  |  |  |
| 820 | 1.4.1.4.1.10.4.2 | Test Management Tool onboarding |  | 31d | 2023-12-04 A | 2024-01-15 A |  | 100% |  | 2023-12-04 | 2024-01-15 | 31d | 2023-09-04 | 2023-11-24 |  | start no earlier than 2023-12-04 |  | PP | SI Test | SIT | 5.0 | Simon Berry | Systems Integration Testing (SIT) | Complete | COMPLETE |  |  |  |  |
| 821 | 1.4.1.4.1.10.5 | **SIT Component Integration Test Readiness Report** |  | 25d | 2023-11-20 A | 2023-12-22 A |  | 100% |  | 2023-11-20 | 2023-12-22 | 25d | 2023-12-18 | 2024-01-19 |  |  |  | N/A | N/A | SIT | 5.0 | N/A | Systems Integration Testing (SIT) |  |  |  |  |  |  |
| 822 | 1.4.1.4.1.10.5.1 | PP submit Test Readiness Report to Programme for assurance | milestone | 0d | 2023-12-08 A | 2023-12-08 A | 614 | 100% |  | 2023-12-08 | 2023-12-08 | 0d | 2024-01-05 | 2024-01-05 |  |  |  | PP | SI Test | SIT | 5.0 |  | Systems Integration Testing (SIT) | Complete | COMPLETE |  |  |  |  |
| 823 | 1.4.1.4.1.10.5.2 | SI assure Test Participants' Test Readiness Reports |  | 5d | 2023-12-11 A | 2023-12-15 A | 822FF+5d | 100% |  | 2023-12-11 | 2023-12-15 | 5d | 2024-01-08 | 2024-01-12 |  |  |  | SI Test | PP,IPA | SIT | 5.0 |  | Systems Integration Testing (SIT) | Complete | COMPLETE |  |  |  |  |
| 824 | 1.4.1.4.1.10.5.3 | SI develop Overarching SIT Component Integration Test Readiness Report |  | 20d | 2023-11-20 A | 2023-12-15 A | 823FF | 100% |  | 2023-11-20 | 2023-12-15 | 20d | 2023-12-18 | 2024-01-12 |  |  |  | SI Test |  | SIT | 5.0 |  | Systems Integration Testing (SIT) | Complete | COMPLETE |  |  |  |  |
| 825 | 1.4.1.4.1.10.5.4 | Artefact review (via TMAG) and updates |  | 5d | 2023-12-18 A | 2023-12-22 A | 824 | 100% |  | 2023-12-18 | 2023-12-22 | 5d | 2024-01-15 | 2024-01-19 |  |  |  | SI Test | PP,IPA | SIT | 5.0 |  | Systems Integration Testing (SIT) | Complete | COMPLETE |  |  |  |  |
| 826 | 1.4.1.4.1.10.6 | SIT Component Integration Testing 6 Preparation Complete (incl. approval of SI SIT Component Integration Test Readiness Report) | milestone | 0d | 2024-01-19 A | 2024-01-19 A | 825FS+1d, 799, 803, 820, 822, 817, 286, 457 | 100% |  | 2024-01-19 | 2024-01-19 | 0d | 2024-01-22 | 2024-01-22 |  |  |  | SI Test | PP,IPA | SIT | 5.15 |  | Systems Integration Testing (SIT) | Complete | COMPLETE | MHHS-ART071 | T2-TE-0500 | SITAG | T2 |
| 827 | 1.4.1.4.2 | **SIT Functional Preparation** |  | 636d? | 2022-10-31 A | 2025-04-07 |  | 85% | 96.4d? | 2022-10-31 | 2025-04-07 | 520d | 2022-10-31 | 2024-03-01 | 708d |  | -0 | N/A | N/A | SIT | 5.0 | N/A | Systems Integration Testing (SIT) |  |  |  |  |  |  |
| 828 | 1.4.1.4.2.1 | Environment Approach and Plan - SIT Functional |  | 1d? | 2023-11-20 A | 2023-11-20 A |  | 100% |  | 2023-11-20 | 2023-11-20 | 0d |  |  |  | start no earlier than 2023-11-20 |  | SI Test |  | SIT | 6.0 |  |  | Complete | COMPLETE |  |  |  |  |
| 829 | 1.4.1.4.2.2 | **Test Approach & Plan** |  | 208d | 2022-10-31 A | 2023-08-16 A |  | 100% |  | 2022-10-31 | 2023-08-16 | 208d | 2022-10-31 | 2023-08-16 |  |  |  | N/A | N/A | SIT | 5.0 | N/A | Systems Integration Testing (SIT) |  |  |  |  |  |  |
| 830 | 1.4.1.4.2.2.1 | Develop document with SITWG |  | 179d | 2022-10-31 A | 2023-07-06 A |  | 100% |  | 2022-10-31 | 2023-07-06 | 179d | 2022-10-31 | 2023-07-06 |  | finish no earlier than 2023-07-06 |  | SI Test |  | SIT | 5.0 |  | Systems Integration Testing (SIT) | Complete | COMPLETE |  |  |  |  |
| 831 | 1.4.1.4.2.2.2 | Industry Consultation |  | 10d | 2023-07-07 A | 2023-07-20 A | 830 | 100% |  | 2023-07-07 | 2023-07-20 | 10d |  |  |  |  |  | PP |  | SIT | 5.1 |  | Systems Integration Testing (SIT) | Complete | COMPLETE |  |  |  |  |
| 832 | 1.4.1.4.2.2.3 | Artefact review (via TMAG) and updates |  | 19d | 2023-07-21 A | 2023-08-16 A | 831 | 100% |  | 2023-07-21 | 2023-08-16 | 19d | 2023-07-07 | 2023-08-03 |  | finish no earlier than 2023-08-03 |  | SI Test | PP,IPA,Code Bodies | SIT | 5.5 |  | Systems Integration Testing (SIT) | Complete | COMPLETE |  |  |  |  |
| 833 | 1.4.1.4.2.2.4 | SIT Functional Test Approach & Plan approved | milestone | 0d | 2023-08-16 A | 2023-08-16 A |  | 100% |  | 2023-08-16 | 2023-08-16 | 0d | 2023-08-16 | 2023-08-16 |  | finish no earlier than 2023-08-16 |  | SI Test | PP | SIT | 5.0 |  | Systems Integration Testing (SIT) | Complete | COMPLETE | MHHS-ART073 | T3-TE-0013 | SITAG | T3 |

Notes:
- 817: Action: 28/7: CH: Needs to be set-up as a reporting milestone. 31/7: Check with Cesar if has been approved so can be baselined

| ID | WBS | Task | Type | Duration | Start | Finish | Predecessors | Complete | Remaining | Baseline start | Baseline finish | Baseline duration | Baseline 1 start | Baseline 1 finish | Total slack | Free slack | Constraint | Baseline cost | Responsible | Involved | Text9 | Update Version | MHHS Resource Name | MHHS Programme Phase | Sched Status | RAG | Artefact ID | Milestone ID | Text29 | Tier | Action | Guidance | Task Status |
| --- | --- | --- | --- | --- | --- | --- | --- | --- | --- | --- | --- | --- | --- | --- | --- | --- | --- | --- | --- | --- | --- | --- | --- | --- | --- | --- | --- | --- | --- | --- | --- | --- | --- |
| 834 | 1.4.1.4.2.3 | **Test Data Approach & Plan** |  | 29d | 2023-07-07 A | 2023-08-16 A |  | 100% |  | 2023-07-07 | 2023-08-16 | 29d | 2023-07-07 | 2023-08-16 |  |  |  |  | N/A | N/A | SIT | 5.0 | N/A | Systems Integration Testing (SIT) |  |  |  |  |  |  |  |  |  |
| 835 | 1.4.1.4.2.3.1 | Industry Consultation |  | 10d | 2023-07-07 A | 2023-07-20 A | 831SS | 100% |  | 2023-07-07 | 2023-07-20 | 10d |  |  |  |  |  |  | PP |  | SIT | 5.1 | Cesar Lopes | Systems Integration Testing (SIT) | Complete | COMPLETE |  |  |  |  |  |  |  |
| 836 | 1.4.1.4.2.3.2 | Artefact review (via TMAG) and updates |  | 19d | 2023-07-21 A | 2023-08-16 A | 835 | 100% |  | 2023-07-21 | 2023-08-16 | 19d | 2023-07-07 | 2023-08-03 |  |  |  |  | SI Test |  | SIT | 5.5 | Cesar Lopes | Systems Integration Testing (SIT) | Complete | COMPLETE |  |  |  |  |  |  |  |
| 837 | 1.4.1.4.2.3.3 | SIT Functional Testing Test Data Approach & Plan approved | milestone | 0d | 2023-08-16 A | 2023-08-16 A | 836 | 100% |  | 2023-08-16 | 2023-08-16 | 0d | 2023-08-16 | 2023-08-16 |  |  |  |  | SI Test | PP,IPA | SIT | 5.5 | Cesar Lopes | Systems Integration Testing (SIT) | Complete | COMPLETE |  |  |  |  |  |  |  |
| 838 | 1.4.1.4.2.4 | **Test scenarios** |  | 298d | 2023-01-02 A | 2024-02-21 A |  | 100% |  | 2023-01-02 | 2024-02-21 | 298d | 2023-01-02 | 2023-06-02 |  |  |  | -0 | N/A | N/A | SIT | 5.0 | N/A | Systems Integration Testing (SIT) |  |  |  |  |  |  |  |  |  |
| 839 | 1.4.1.4.2.4.1 | Development of test scenarios |  | 85d | 2023-01-02 A | 2023-04-28 A | 830SS+45d | 100% |  | 2023-01-02 | 2023-04-28 | 85d | 2023-01-02 | 2023-04-28 |  |  |  |  | SI Test | PP, Code Bodies | SIT | 5.0 |  | Systems Integration Testing (SIT) | Complete | COMPLETE |  |  |  |  |  |  |  |
| 840 | 1.4.1.4.2.4.2 | Review test scenarios with SIT Working Group |  | 65d | 2023-08-17 A | 2023-11-15 A | 839FS+78d | 100% |  | 2023-08-17 | 2023-11-15 | 65d | 2023-02-01 | 2023-05-26 |  |  |  |  | SI Test | PP, Code Bodies, IPA | SIT | 5.0 |  | Systems Integration Testing (SIT) | Complete | COMPLETE |  |  |  |  |  |  |  |
| 841 | 1.4.1.4.2.4.3 | SIT Functional Testing Test scenarios (themes 1-5) approved | milestone | 0d | 2023-12-08 A | 2023-12-08 A | 840FS+17d | 100% |  | 2023-12-08 | 2023-12-08 | 0d | 2023-06-02 | 2023-06-02 |  |  |  |  | SI Test | PP | SIT | 5.14 |  | Systems Integration Testing (SIT) | Complete | COMPLETE | MMHS-ART073 | T3-TE-0015 | SITAG | T3 |  |  |  |
| 842 | 1.4.1.4.2.4.4 | SIT Functional Testing Test scenarios (themes 6,7,9) approved | milestone | 0d | 2024-01-17 A | 2024-01-17 A | 841FS+28d | 100% |  | 2024-01-17 | 2024-01-17 | 0d | 2023-06-02 | 2023-06-02 |  |  |  |  | SI Test | PP | SIT | 5.16 |  | Systems Integration Testing (SIT) | Complete | COMPLETE | MMHS-ART073 | T3-TE-0106 | SITAG | T3 |  |  |  |
| 843 | 1.4.1.4.2.4.5 | SIT Functional Testing Test scenarios (theme 8) approved | milestone | 0d | 2024-02-21 A | 2024-02-21 A | 842FS+25d | 100% |  | 2024-02-21 | 2024-02-21 | 0d | 2023-06-02 | 2023-06-02 |  |  |  |  | SI Test | PP | SIT | 5.14 |  | Systems Integration Testing (SIT) | Complete | COMPLETE | MMHS-ART073 | T3-TE-0107 | SITAG | T3 |  |  |  |
| 844 | 1.4.1.4.2.5 | **Test cases** |  | 465d? | 2023-05-01 A | 2025-02-07 |  | 80% | 94.33d? | 2023-05-01 | 2025-02-07 | 213d | 2023-05-01 | 2023-09-01 | 749d |  |  |  | N/A | N/A | SIT | 5.0 | N/A | Systems Integration Testing (SIT) |  |  |  |  |  |  | 25/7 - needs to be replanned |  |  |
| 845 | 1.4.1.4.2.5.1 | **SI Test cases** |  | 213d | 2023-05-01 A | 2024-02-21 A |  | 100% |  | 2023-05-01 | 2024-02-21 | 213d | 2023-05-01 | 2023-09-01 |  |  |  |  | N/A | N/A | SIT | 5.0 | N/A | Systems Integration Testing (SIT) |  |  |  |  |  |  | 25/7 - needs to be replanned |  |  |
| 846 | 1.4.1.4.2.5.1.1 | Development of Test cases |  | 150d | 2023-05-01 A | 2023-11-24 A | 839 | 100% |  | 2023-05-01 | 2023-11-24 | 150d | 2023-05-01 | 2023-07-28 |  |  |  |  | SI Test |  | SIT | 5.0 |  | Systems Integration Testing (SIT) | Complete | COMPLETE |  |  |  |  | 25/7 - needs to be replanned |  |  |
| 847 | 1.4.1.4.2.5.1.2 | Review Test cases with SIT Working Group |  | 78d | 2023-09-25 A | 2024-01-10 A | 846SS+105d | 100% |  | 2023-09-25 | 2024-01-10 | 78d | 2023-05-26 | 2023-08-25 |  |  |  |  | SI Test | PP,IPA | SIT | 5.0 |  | Systems Integration Testing (SIT) | Complete | COMPLETE |  |  |  |  | 25/7 - needs to be replanned |  |  |
| 848 | 1.4.1.4.2.5.1.3 | SIT Functional Testing Test Cases (themes 1-5) approved | milestone | 0d | 2024-01-17 A | 2024-01-17 A | 847FS+5d | 100% |  | 2024-01-17 | 2024-01-17 | 0d | 2023-09-01 | 2023-09-01 |  |  |  |  | SI Test | PP | SIT | 5.14 |  | Systems Integration Testing (SIT) | Complete | COMPLETE | MHHS-ART140 | T3-TE-0070 | SITAG | T3 |  | 2/1/24 - Approved at Dec TMAG |  |
| 849 | 1.4.1.4.2.5.1.4 | SIT Functional Testing Test cases (themes 6,7,9) approved | milestone | 0d | 2024-01-17 A | 2024-01-17 A | 848 | 100% |  | 2024-01-17 | 2024-01-17 | 0d | 2023-09-01 | 2023-09-01 |  |  |  |  | SI Test | PP | SIT | 5.14 |  | Systems Integration Testing (SIT) | Complete | COMPLETE | MHHS-ART140 | T3-TE-0108 | SITAG | T3 |  |  |  |
| 850 | 1.4.1.4.2.5.1.5 | SIT Functional Testing Test cases (theme 8) approved | milestone | 0d | 2024-02-21 A | 2024-02-21 A | 849FS+25d | 100% |  | 2024-02-21 | 2024-02-21 | 0d | 2023-09-01 | 2023-09-01 |  |  |  |  | SI Test | PP | SIT | 5.14 |  | Systems Integration Testing (SIT) | Complete | COMPLETE | MHHS-ART140 | T3-TE-0109 | SITAG | T3 |  |  |  |
| 851 | 1.4.1.4.2.5.2 | **SIT Functional Programme RTTM** |  | 72d? | 2024-07-29 A | 2024-11-05 |  | 77% | 16.52d? | 2024-07-29 | 2024-10-11 | 0d |  |  | 817d |  |  |  |  |  | SIT | 6.0 |  |  | Overdue Start |  |  |  |  |  |  |  | -687.67 |
| 852 | 1.4.1.4.2.5.2.1 | **RTTM Development** |  | 40d? | 2024-07-29 A | 2024-09-20 |  | 89% | 4.57d? | 2024-07-29 | 2024-09-20 | 0d |  |  | 849d |  |  |  |  |  | SIT | 6.0 |  |  | Overdue Start |  |  |  |  |  |  |  | -693.67 |
| 853 | 1.4.1.4.2.5.2.1.1 | Development of Manual SIT Functional RTTM |  | 30d? | 2024-07-29 A | 2024-09-06 A |  | 100% |  | 2024-07-29 | 2024-09-06 | 0d |  |  |  |  | start no earlier than 2024-07-29 |  |  |  | SIT | 6.0 |  |  | Complete | COMPLETE |  |  |  |  |  |  |  |
| 854 | 1.4.1.4.2.5.2.1.2 | Manual SIT Functional RTTM Complete | milestone | 0d? | 2024-09-06 A | 2024-09-06 A | 853 | 100% |  | 2024-09-06 | 2024-09-06 | 0d |  |  |  |  | start no earlier than 2024-07-29 |  |  |  | SIT | 6.0 |  |  | Complete | COMPLETE |  |  |  |  |  |  |  |
| 855 | 1.4.1.4.2.5.2.1.3 | Development of Automated SIT Functional RTTM |  | 40d? | 2024-07-29 A | 2024-09-20 |  | 80% | 8d? | 2024-07-29 | 2024-09-20 | 0d |  |  | 849d | 0d | start no earlier than 2024-07-29 |  |  |  | SIT | 6.0 |  |  | Overdue | RED |  |  |  |  |  |  |  |
| 856 | 1.4.1.4.2.5.2.1.4 | Automated SIT Functional RTTM Complete | milestone | 0d? | 2024-09-20 A | 2024-09-20 | 855 | 80% | 0d? | 2024-09-20 | 2024-09-20 | 0d |  |  | 849d |  | finish no earlier than 2024-09-20 |  |  |  | SIT | 6.0 |  |  | Overdue | RED |  |  |  |  |  |  |  |
| 857 | 1.4.1.4.2.5.2.2 | **Gap analysis** |  | 52d? | 2024-08-26 A | 2024-11-05 |  | 69% | 16.12d? | 2024-08-26 | 2024-10-11 | 0d |  |  | 817d |  |  |  |  |  | SIT | 6.0 |  |  | Overdue Start |  |  |  |  |  |  |  | -693.67 |
| 858 | 1.4.1.4.2.5.2.2.1 | Identify gaps in test case coverage following RTTM review |  | 20d? | 2024-08-26 A | 2024-09-20 A | 855SS+20d | 100% |  | 2024-08-26 | 2024-09-20 | 0d |  |  |  |  |  |  |  |  | SIT | 6.0 |  |  | Complete | COMPLETE |  |  |  |  |  |  |  |
| 859 | 1.4.1.4.2.5.2.2.2 | Address gaps in test case coverage following RTTM review |  | 25d | 2024-09-09 A | 2024-10-11 | 858SS+10d | 80% | 5d | 2024-09-09 | 2024-10-04 | 0d |  |  | 834d |  |  |  |  |  | SIT | 6.0 |  |  | Overdue | RED |  |  |  |  |  |  |  |
| 860 | 1.4.1.4.2.5.2.2.3 | Gap analysis complete | milestone | 0d | 2024-10-11 A | 2024-10-11 A | 859 | 100% |  | 2024-10-11 | 2024-10-11 | 0d |  |  |  |  |  |  |  |  | SIT | 6.11 |  |  | Complete | COMPLETE |  |  |  |  |  |  |  |
| 861 | 1.4.1.4.2.5.2.2.4 | Test Script updates identified |  | 1d? | 2024-10-14 A | 2024-10-14 A | 860 | 100% |  | 2024-10-14 | 2024-10-14 | 0d |  |  |  |  |  |  |  |  | SIT | 6.11 |  |  | Complete | COMPLETE |  |  |  |  |  |  |  |
| 862 | 1.4.1.4.2.5.2.2.5 | Test Scripts updates |  | 1d | 2024-10-15 A | 2024-10-15 A | 861 | 100% |  | 2024-10-15 | 2024-10-15 | 0d |  |  |  |  |  |  |  |  | SIT | 6.11 |  |  | Complete | COMPLETE |  |  |  |  |  |  |  |
| 863 | 1.4.1.4.2.5.2.2.6 | RTTM Updated Additional Static RTTM WBS items |  | 10d | 2024-10-14 A | 2024-10-25 A | 861FS-1d | 100% |  | 2024-10-14 | 2024-10-25 | 0d |  |  |  |  |  |  |  |  | SIT | 6.11 |  |  | Complete | COMPLETE |  |  |  |  |  |  |  |
| 864 | 1.4.1.4.2.5.2.2.7 | Removal of de-scoped TCs from the RTTMs |  | 5d | 2024-10-21 A | 2024-10-25 A | 863FS-5d | 100% |  | 2024-10-21 | 2024-10-25 | 0d |  |  |  |  |  |  |  |  | SIT | 6.11 |  |  | Complete | COMPLETE |  |  |  |  |  |  |  |
| 865 | 1.4.1.4.2.5.2.2.8 | Update and stabilisation of all TC ADO IDs |  | 5d | 2024-10-21 A | 2024-10-25 | 863FS-5d | 50% | 2.5d | 2024-10-21 | 2024-10-25 | 0d |  |  | 824d |  |  |  |  |  | SIT | 6.11 |  |  | Green | RED |  |  |  |  |  |  |  |
| 866 | 1.4.1.4.2.5.2.2.9 | Addition and integration of Role tags to reqs in the Role RTTMs |  | 5d | 2024-10-21 A | 2024-10-25 A | 863FS-5d | 100% |  | 2024-10-21 | 2024-10-25 | 0d |  |  |  |  |  |  |  |  | SIT | 6.11 |  |  | Complete | COMPLETE |  |  |  |  |  |  |  |
| 867 | 1.4.1.4.2.5.2.2.10 | Update of the RTTM All sheet (porting of the individual RTTMs) |  | 7d | 2024-10-24 A | 2024-11-01 | 863FS-2d | 50% | 3.5d | 2024-10-24 | 2024-10-25 | 0d |  |  | 740d | 0d |  |  |  |  | SIT | 6.11 |  |  | yellow | RED |  |  |  |  |  |  |  |
| 868 | 1.4.1.4.2.5.2.2.11 | Define Additional ADO Tags |  | 1d | 2024-10-23 A | 2024-10-23 A | 863FS-3d | 100% |  | 2024-10-23 | 2024-10-23 | 0d |  |  |  |  |  |  |  |  | SIT | 6.11 |  |  | Complete | COMPLETE |  |  |  |  |  |  |  |
| 869 | 1.4.1.4.2.5.2.2.12 | Functional RTTM ready for import into ADO | milestone | 0d | 2024-11-01 | 2024-11-01 | 867 |  |  | 2024-10-25 | 2024-10-25 | 0d |  |  | 819d |  |  |  |  |  | SIT | 6.11 |  |  | yellow | RED |  |  |  |  |  |  | 1.71 |
| 870 | 1.4.1.4.2.5.2.2.13 | Further Interative Deepdive on the requirements to testcase mapping |  | 9d | 2024-10-21 | 2024-10-31 | 867FS-10d |  |  | 2024-10-21 | 2024-10-31 | 0d |  |  | 740d | 0d |  |  |  |  | SIT | 6.11 |  |  | Overdue Start | GREEN |  |  |  |  |  |  | -9.67 |
| 871 | 1.4.1.4.2.5.2.2.14 | Internal review |  | 5d | 2024-10-21 | 2024-10-25 | 870FS-9d |  |  | 2024-11-01 | 2024-11-05 | 0d |  |  | 740d | 0d |  |  |  |  | SIT | 6.11 |  |  | Overdue Start | GREEN |  |  |  |  |  |  | -9.67 |
| 872 | 1.4.1.4.2.5.2.2.15 | Issue Static RTTM to Code Bodies |  | 1d? | 2024-10-29 | 2024-10-29 | 871FS+1d |  |  | 2024-11-06 | 2024-11-06 | 0d |  |  | 740d | 0d |  |  |  |  | SIT | 6.11 |  |  | Green | GREEN |  |  |  |  |  |  | -1.67 |
| 873 | 1.4.1.4.2.5.2.2.16 | Code Body Acceptance of RTTM |  | 5d | 2024-10-30 | 2024-11-05 | 872 |  |  | 2024-11-07 | 2024-11-13 | 0d |  |  | 740d | 0d |  |  |  |  | SIT | 6.11 |  |  | Green | GREEN |  |  |  |  |  |  | -0.67 |

| ID | WBS | Task | Type | Duration | Start | Finish | Predecessors | Complete | Remaining | Baseline start | Baseline finish | Baseline duration | Total slack | Free slack | Constraint | Text9 | Task Status | Update Version | Sched Status | RAG |
| --- | --- | --- | --- | --- | --- | --- | --- | --- | --- | --- | --- | --- | --- | --- | --- | --- | --- | --- | --- | --- |
| 874 | 1.4.1.4.2.5.3 | **Cycle 3 Test Evidence Capturing Approach** |  | 25d? | 2024-09-16 A | 2024-10-18 A |  | 100% |  | 2024-09-16 | 2024-10-18 | 0d |  |  |  | SIT | -692.67 | 6.0 | Overdue Start | GREEN |
| 875 | 1.4.1.4.2.5.3.1 | Define guiding principles and proof of concept |  | 10d | 2024-09-16 A | 2024-09-27 A |  | 100% |  | 2024-09-16 | 2024-09-27 | 0d |  |  | start no earlier than 2024-09-16 | SIT |  | 6.0 | Complete | COMPLETE |
| 876 | 1.4.1.4.2.5.3.2 | Draft proposed test evidence capturing approach |  | 3d | 2024-09-30 A | 2024-10-02 A | 875 | 100% |  | 2024-09-30 | 2024-10-02 | 0d |  |  |  | SIT |  | 6.0 | Complete | COMPLETE |
| 877 | 1.4.1.4.2.5.3.3 | SRO review |  | 5d | 2024-10-03 A | 2024-10-09 A | 876 | 100% |  | 2024-10-03 | 2024-10-09 | 0d |  |  |  | SIT |  | 6.0 | Complete | COMPLETE |
| 878 | 1.4.1.4.2.5.3.4 | Present proposed approach |  | 1d? | 2024-10-11 A | 2024-10-11 A | 877FS+1d | 100% |  | 2024-10-11 | 2024-10-11 | 0d |  |  |  | SIT |  | 6.0 | Complete | COMPLETE |
| 879 | 1.4.1.4.2.5.3.5 | Incorporate feedback |  | 4d | 2024-10-14 A | 2024-10-17 A | 878 | 100% |  | 2024-10-14 | 2024-10-17 | 0d |  |  |  | SIT |  | 6.0 | Complete | COMPLETE |
| 880 | 1.4.1.4.2.5.3.6 | Publish proposed approach ahead of Cycle 3 start |  | 1d? | 2024-10-18 A | 2024-10-18 A | 879 | 100% |  | 2024-10-18 | 2024-10-18 | 0d |  |  |  | SIT |  | 6.0 | Complete | COMPLETE |
| 881 | 1.4.1.4.2.5.4 | **DITL Cycle 3 Pack Development** |  | 8d? | 2024-10-08 A | 2024-10-17 |  | 31% | 5.5d? | 2024-10-08 | 2024-10-17 | 0d | 830d |  |  | SIT | 6.33 | 6.0 | No BL | GREEN |
| 882 | 1.4.1.4.2.5.4.1 | Programme Cycle 2 Retro |  | 1d? | 2024-10-08 A | 2024-10-08 A |  | 100% |  | 2024-10-08 | 2024-10-08 | 0d |  |  | start no earlier than 2024-10-08 | SIT |  | 6.0 | Complete | COMPLETE |
| 883 | 1.4.1.4.2.5.4.2 | Post-retro DITL Changes |  | 3d | 2024-10-09 A | 2024-10-11 | 882 | 50% | 1.5d | 2024-10-09 | 2024-10-11 | 0d | 830d | 0d |  | SIT |  | 6.0 | Overdue | RED |
| 884 | 1.4.1.4.2.5.4.3 | SRO Review |  | 2d | 2024-10-14 | 2024-10-15 | 883 |  |  | 2024-10-14 | 2024-10-15 | 0d | 830d | 0d |  | SIT | -16.67 | 6.0 | Overdue Start | RED |
| 885 | 1.4.1.4.2.5.4.4 | Post-SRO Review Changes |  | 1d? | 2024-10-16 | 2024-10-16 | 884 |  |  | 2024-10-16 | 2024-10-16 | 0d | 830d | 0d |  | SIT | -14.67 | 6.0 | Overdue Start | RED |
| 886 | 1.4.1.4.2.5.4.5 | Publish Cycle 3 DITL / Cycle 3 DITL Online Sessions for SIT PPs |  | 1d? | 2024-10-17 | 2024-10-17 | 885 |  |  | 2024-10-17 | 2024-10-17 | 0d | 830d |  |  | SIT | -13.67 | 6.0 | Overdue Start | RED |
| 887 | 1.4.1.4.2.5.5 | **Test Script Exit Points** |  | 85d | 2024-10-14 A | 2025-02-07 |  | 7% | 79.33d | 2024-10-14 | 2025-02-07 | 0d | 749d |  |  | SIT | -694.67 | 6.0 | Overdue Start | GREEN |
| 888 | 1.4.1.4.2.5.5.1 | Implement exit points for Sprint 5 |  | 5d | 2024-10-14 A | 2024-10-18 | 880FS-5d | 60% | 2d | 2024-10-14 | 2024-10-18 | 0d | 829d |  |  | SIT |  | 6.0 | Overdue | RED |
| 889 | 1.4.1.4.2.5.5.2 | Identify exit points for Sprint 6 |  | 5d | 2024-10-21 | 2024-10-25 | 1350SS |  |  | 2024-10-21 | 2024-10-25 | 0d | 824d |  |  | SIT | -9.67 | 6.0 | Overdue Start | AMBER |
| 890 | 1.4.1.4.2.5.5.3 | Identify exit points for Sprint 7 |  | 5d | 2024-11-04 | 2024-11-08 | 1351SS |  |  | 2024-11-04 | 2024-11-08 | 0d | 814d |  |  | SIT | 4.33 | 6.0 | Green | GREEN |
| 891 | 1.4.1.4.2.5.5.4 | Identify exit points for Sprint 8 |  | 5d | 2024-11-18 | 2024-11-22 | 1352SS |  |  | 2024-11-18 | 2024-11-22 | 0d | 804d |  |  | SIT | 18.33 | 6.0 | Green | GREEN |
| 892 | 1.4.1.4.2.5.5.5 | Identify exit points for Sprint 9 |  | 5d | 2024-12-02 | 2024-12-06 | 1353SS |  |  | 2024-12-02 | 2024-12-06 | 0d | 794d |  |  | SIT | 32.33 | 6.0 | Green | GREEN |
| 893 | 1.4.1.4.2.5.5.6 | Identify exit points for Sprint 10 |  | 5d | 2024-12-23 | 2024-12-27 | 1354SS |  |  | 2024-12-23 | 2024-12-27 | 0d | 779d |  |  | SIT | 53.33 | 6.0 | Green | GREEN |
| 894 | 1.4.1.4.2.5.5.7 | Identify exit points for Sprint 11 |  | 5d | 2025-01-06 | 2025-01-10 | 1355SS |  |  | 2025-01-06 | 2025-01-10 | 0d | 769d |  |  | SIT | 67.33 | 6.0 | Green | GREEN |
| 895 | 1.4.1.4.2.5.5.8 | Identify exit points for Sprint 12 |  | 5d | 2025-01-20 | 2025-01-24 | 1356SS |  |  | 2025-01-20 | 2025-01-24 | 0d | 759d |  |  | SIT | 81.33 | 6.0 | Green | GREEN |
| 896 | 1.4.1.4.2.5.5.9 | Identify exit points for Sprint 13 |  | 5d | 2025-02-03 | 2025-02-07 | 1357SS |  |  | 2025-02-03 | 2025-02-07 | 0d | 749d |  |  | SIT | 95.33 | 6.0 | Green | GREEN |
| 897 | 1.4.1.4.2.5.6 | **Cycle 3 Test Case Rationalisation (Functional)** |  | 36d? | 2024-09-16 A | 2024-11-04 |  | 60% | 14.4d? | 2024-09-16 | 2024-11-04 | 0d | 818d |  |  | SIT | -692.67 | 6.0 | Overdue Start | GREEN |
| 898 | 1.4.1.4.2.5.6.1 | Review Cycle 3 scope and identify candidates for rationalisation |  | 25d | 2024-09-16 A | 2024-10-18 |  | 60% | 10d | 2024-09-16 | 2024-10-18 | 0d | 829d |  | start no earlier than 2024-09-16 | SIT |  | 6.0 | Overdue | RED |
| 899 | 1.4.1.4.2.5.6.2 | Define proposal for rationalisation of test cases |  | 15d | 2024-09-30 A | 2024-10-18 A | 898 | 100% |  | 2024-09-30 | 2024-10-18 | 0d |  |  |  | SIT |  | 6.0 | Complete | COMPLETE |
| 900 | 1.4.1.4.2.5.6.3 | SRO review |  | 5d | 2024-10-21 | 2024-10-25 | 899 |  |  | 2024-10-21 | 2024-10-25 | 0d | 818d | 0d |  | SIT | -9.67 | 6.0 | Overdue Start | GREEN |
| 901 | 1.4.1.4.2.5.6.4 | Present proposed approach |  | 1d? | 2024-10-28 | 2024-10-28 | 900 |  |  | 2024-10-28 | 2024-10-28 | 0d | 818d | 0d |  | SIT | -2.67 | 6.0 | Green | GREEN |
| 902 | 1.4.1.4.2.5.6.5 | Incorporate feedback |  | 4d | 2024-10-29 | 2024-11-01 | 901 |  |  | 2024-10-29 | 2024-11-01 | 0d | 818d | 0d |  | SIT | -1.67 | 6.0 | Green | GREEN |
| 903 | 1.4.1.4.2.5.6.6 | Publish proposed approach ahead of Cycle 3 start | milestone | 0d | 2024-11-04 | 2024-11-04 | 902FS+1d |  |  | 2024-11-04 | 2024-11-04 | 0d | 818d |  |  | SIT | 4.71 | 6.0 | Green | GREEN |

| ID | WBS | Task | Type | Duration | Start | Finish | Predecessors | Complete | Remaining | Baseline start | Baseline finish | Baseline duration | Baseline 1 start | Baseline 1 finish | Total slack | Constraint | Baseline cost | Responsible | Involved | Text9 | Update Version | MHHS Resource Name | MHHS Programme Phase | Task Status | Sched Status | RAG | Action | Milestone ID | Text29 | Tier | Artefact ID |
| --- | --- | --- | --- | --- | --- | --- | --- | --- | --- | --- | --- | --- | --- | --- | --- | --- | --- | --- | --- | --- | --- | --- | --- | --- | --- | --- | --- | --- | --- | --- | --- |
| 904 | 1.4.1.4.2.6 | **Environments (SIT-Staging)** |  | 10d | 2023-12-04 A | 2023-12-15 A |  | 100% |  | 2023-12-04 | 2023-12-15 | 323d | 2022-11-16 | 2024-02-09 |  |  |  | N/A | N/A | SIT | 5.0 | N/A | Systems Integration Testing (SIT) |  |  |  |  |  |  |  |  |
| 905 | 1.4.1.4.2.6.1 | **SIT Functional pre-requisites** |  | 10d | 2023-12-04 A | 2023-12-15 A |  | 100% |  | 2023-12-04 | 2023-12-15 | 10d |  |  |  |  |  | N/A | N/A | SIT | 5.3 | N/A | Systems Integration Testing (SIT) |  |  |  |  |  |  |  |  |
| 906 | 1.4.1.4.2.6.1.1 | **DCC** |  | 10d | 2023-12-04 A | 2023-12-15 A |  | 100% |  | 2023-12-04 | 2023-12-15 | 10d |  |  |  |  |  | N/A | N/A | SIT | 5.3 | N/A | Systems Integration Testing (SIT) | -254.67 |  |  |  |  |  |  |  |
| 907 | 1.4.1.4.2.6.1.1.1 | **CSS** |  | 10d | 2023-12-04 A | 2023-12-15 A |  | 100% |  | 2023-12-04 | 2023-12-15 | 10d |  |  |  |  |  | N/A | N/A | SIT | 5.3 | N/A | Systems Integration Testing (SIT) | -254.67 |  |  |  |  |  |  |  |
| 908 | 1.4.1.4.2.6.1.1.1.1 | SIT participants have requested DCC CSS PKI certificates for access to UIT-B environment |  | 10d | 2023-12-04 A | 2023-12-15 A |  | 100% |  | 2023-12-04 | 2023-12-15 | 10d |  |  |  | start no earlier than 2023-12-04 |  | SIT Participants (Suppliers & Third Parties) | PP | SIT | 5.3 | Simon Berry | Systems Integration Testing (SIT) |  | Complete | COMPLETE |  |  |  |  |  |
| 909 | 1.4.1.4.2.6.1.1.1.2 | SIT participants have received DCC CSS PKI certificates for UIT-B environment | milestone | 0d | 2023-12-15 A | 2023-12-15 A | 908 | 100% |  | 2023-12-15 | 2023-12-15 | 0d |  |  |  |  |  | SIT Participants (Suppliers & Third Parties) | PP | SIT | 5.5 | Simon Berry | Systems Integration Testing (SIT) |  | Complete | COMPLETE | 7/8 - added as a T3 milestone. Awaiting approval at TMAG | T3-TE-0088 | SITAG | T3 |  |
| 910 | 1.4.1.4.2.6.1.1.2 | **DSP** |  | 10d | 2023-12-04 A | 2023-12-15 A |  | 100% |  | 2023-12-04 | 2023-12-15 | 10d |  |  |  |  |  | N/A | N/A | SIT | 5.3 | N/A | Systems Integration Testing (SIT) | -254.67 |  |  |  |  |  |  |  |
| 911 | 1.4.1.4.2.6.1.1.2.1 | SIT participants have requested DCC DSP PKI certificates for access to UIT-B environment |  | 10d | 2023-12-04 A | 2023-12-15 A |  | 100% |  | 2023-12-04 | 2023-12-15 | 10d |  |  |  | start no earlier than 2023-12-04 |  | PPs in SDS Market Role | PP | SIT | 5.3 | Simon Berry | Systems Integration Testing (SIT) |  | Complete | COMPLETE |  |  |  |  |  |
| 912 | 1.4.1.4.2.6.1.1.2.2 | SIT participants have received DCC DSP PKI certificates for UIT-B environment | milestone | 0d | 2023-12-15 A | 2023-12-15 A | 911 | 100% |  | 2023-12-15 | 2023-12-15 | 0d |  |  |  |  |  | PPs in SDS Market Role | PP | SIT | 5.5 | Simon Berry | Systems Integration Testing (SIT) |  | Complete | COMPLETE | 7/8 - added as a T3 milestone. Awaiting approval at TMAG | T3-TE-0089 | SITAG | T3 |  |
| 913 | 1.4.1.4.2.7 | **Stand up SIT A Environment** |  | 25d | 2024-02-05 A | 2024-03-08 A |  | 100% |  | 2024-02-05 | 2024-03-08 | 25d | 2024-02-05 | 2024-02-09 |  |  |  | N/A | N/A | SIT | 6.0 | N/A | Systems Integration Testing (SIT) |  |  |  |  |  |  |  |  |
| 914 | 1.4.1.4.2.7.1 | **SIT Functional Connectivity Proving** |  | 15d | 2024-02-12 A | 2024-03-01 A |  | 100% |  | 2024-02-12 | 2024-03-01 | 20d |  |  |  |  |  | N/A | N/A | SIT | 5.5 | N/A | Systems Integration Testing (SIT) | -288.67 |  |  |  |  |  |  |  |
| 915 | 1.4.1.4.2.7.1.1 | SIT Functional Connectivity Proving Period |  | 15d | 2024-02-12 A | 2024-03-01 A |  | 100% |  | 2024-02-12 | 2024-03-01 | 20d |  |  |  | start no earlier than 2024-01-08 |  | SI Test | PP | SIT | 5.19 | Simon Berry | Systems Integration Testing (SIT) |  | Complete | COMPLETE |  |  |  |  |  |
| 916 | 1.4.1.4.2.7.1.2 | SIT Functional Connectivity Proving Complete | milestone | 0d | 2024-03-01 A | 2024-03-01 A | 915 | 100% |  | 2024-03-01 | 2024-03-01 | 0d |  |  |  | start no earlier than 2024-03-01 |  | SI Test | PP | SIT | 5.19 | Simon Berry | Systems Integration Testing (SIT) |  | Complete | COMPLETE |  | T3-TE-0103 | SITAG | T3 |  |
| 917 | 1.4.1.4.2.7.2 | **PP Environments (SIT A)** |  | 25d | 2024-02-05 A | 2024-03-08 A |  | 100% |  | 2024-02-05 | 2024-03-08 | 5d | 2024-02-05 | 2024-02-09 |  |  |  | N/A | N/A | SIT | 5.0 | N/A | Systems Integration Testing (SIT) |  |  |  |  |  |  |  |  |
| 918 | 1.4.1.4.2.7.2.1 | Deployment of MHHS solution code to SIT A environments |  | 25d | 2024-02-05 A | 2024-03-08 A |  | 100% |  | 2024-02-05 | 2024-03-08 | 5d | 2024-02-05 | 2024-02-09 |  | start no earlier than 2024-02-05 |  | PP | SI Test | SIT | 5.0 | Simon Berry | Systems Integration Testing (SIT) |  | Complete | COMPLETE |  |  |  |  |  |
| 919 | 1.4.1.4.2.7.3 | **SI Environments (SIT A)** |  | 25d | 2024-02-05 A | 2024-03-08 A |  | 100% |  | 2024-02-05 | 2024-03-08 | 5d | 2024-02-05 | 2024-02-09 |  |  |  | N/A | N/A | SIT | 5.0 | N/A | Systems Integration Testing (SIT) |  |  |  |  |  |  |  |  |
| 920 | 1.4.1.4.2.7.3.1 | Coordinate deployment of MHHS solution code to SIT Participants' SIT A environments |  | 25d | 2024-02-05 A | 2024-03-08 A | 918SS | 100% |  | 2024-02-05 | 2024-03-08 | 5d | 2024-02-05 | 2024-02-09 |  |  |  | SI Test | PP | SIT | 5.0 | Simon Berry | Systems Integration Testing (SIT) |  | Complete | COMPLETE |  |  |  |  |  |
| 921 | 1.4.1.4.2.8 | **Test data (SIT A)** |  | 341d? | 2023-12-18 A | 2025-04-07 |  | 65% | 120.49d? | 2023-12-18 | 2025-04-07 | 225d |  |  | 34d |  | -0 | N/A | N/A | SIT | 5.4 | N/A | Systems Integration Testing (SIT) | -269.67 |  |  |  |  |  |  |  |
| 922 | 1.4.1.4.2.8.1 | **Cycle 1 Test data (SIT A)** |  | 55d | 2023-12-18 A | 2024-03-01 A |  | 100% |  | 2023-12-18 | 2024-03-01 | 55d |  |  |  |  | -0 | N/A | N/A | SIT | 5.4 | N/A | Systems Integration Testing (SIT) | -269.67 |  |  |  |  |  |  |  |
| 923 | 1.4.1.4.2.8.1.1 | Prepare, Generate and Allocate Test Data |  | 28d | 2023-12-18 A | 2024-01-24 A | 646, 654 | 100% |  | 2023-12-18 | 2024-01-24 | 28d |  |  |  | start no earlier than 2023-12-11 |  | SI Test Data |  | SIT | 5.14 | Richard Puddephatt | Systems Integration Testing (SIT) |  | Complete | COMPLETE |  |  |  |  |  |
| 924 | 1.4.1.4.2.8.1.2 | Transmit Data Sets to PPs |  | 4d | 2024-01-26 A | 2024-01-31 A | 923FS+1d | 100% |  | 2024-01-26 | 2024-01-31 | 2d |  |  |  |  |  | SI Test Data |  | SIT | 5.14 | Richard Puddephatt | Systems Integration Testing (SIT) |  | Complete | COMPLETE |  |  |  |  |  |
| 925 | 1.4.1.4.2.8.1.3 | PP's Iterative load and data integrity check |  | 22d | 2024-02-01 A | 2024-03-01 A | 924 | 100% |  | 2024-02-01 | 2024-03-01 | 10d |  |  |  |  |  | PP |  | SIT | 5.14 | Richard Puddephatt | Systems Integration Testing (SIT) |  | Complete | COMPLETE |  |  |  |  |  |
| 926 | 1.4.1.4.2.8.1.4 | Cycle 1 - PP's confirmation that test data is ready for SIT Functional | milestone | 0d | 2024-03-01 A | 2024-03-01 A | 925 | 100% |  | 2024-03-01 | 2024-03-01 | 0d |  |  |  |  |  | SI Test Data |  | SIT | 5.18 | Richard Puddephatt | Systems Integration Testing (SIT) |  | Complete | COMPLETE | 2/8 - added as a T3 milestone. Awaiting approval at TMAG | T3-TE-0079 | SITAG | T3 | MHHS-ART140 MHHS-ART169 |
| 927 | 1.4.1.4.2.8.2 | **Cycle 2 Test data (inc. Settlement Data) (SIT A)** |  | 57d | 2024-03-28 A | 2024-06-14 A |  | 100% |  | 2024-03-28 | 2024-06-14 | 47d |  |  |  |  | -0 | N/A | N/A | SIT | 6.0 | N/A | Systems Integration Testing (SIT) |  |  |  |  |  |  |  |  |
| 928 | 1.4.1.4.2.8.2.1 | Prepare, Generate and Allocate Test Data |  | 31d | 2024-03-28 A | 2024-05-09 A | 926FS+18d | 100% |  | 2024-03-28 | 2024-05-09 | 31d |  |  |  |  |  | SI Test Data |  | SIT | 5.14 | Richard Puddephatt | Systems Integration Testing (SIT) |  | Complete | COMPLETE |  |  |  |  |  |
| 929 | 1.4.1.4.2.8.2.2 | Transmit Data Sets to PPs |  | 3d | 2024-05-10 A | 2024-05-14 A | 928 | 100% |  | 2024-05-10 | 2024-05-14 | 3d |  |  |  |  |  | SI Test Data |  | SIT | 5.14 | Richard Puddephatt | Systems Integration Testing (SIT) |  | Complete | COMPLETE |  |  |  |  |  |
| 930 | 1.4.1.4.2.8.2.3 | PP's Iterative load and data integrity check |  | 13d | 2024-05-15 A | 2024-05-31 A | 929 | 100% |  | 2024-05-15 | 2024-05-31 | 13d |  |  |  |  |  | PP |  | SIT | 5.14 | Richard Puddephatt | Systems Integration Testing (SIT) |  | Complete | COMPLETE |  |  |  |  |  |
| 931 | 1.4.1.4.2.8.2.4 | Cycle 2 - PP's confirmation that test data is ready for SIT Functional | milestone | 0d | 2024-06-14 A | 2024-06-14 A | 930FS+10d | 100% |  | 2024-06-14 | 2024-06-14 | 0d |  |  |  |  |  | SI Test Data |  | SIT | 5.27 | Richard Puddephatt | Systems Integration Testing (SIT) |  | Complete | COMPLETE | 2/8 - added as a T3 milestone. Awaiting approval at TMAG | T3-TE-0080 | SITAG | T3 | MHHS-ART140 MHHS-ART169 |

| ID | WBS | Task | Type | Duration | Start | Finish | Predecessors | Complete | Remaining | Baseline start | Baseline finish | Baseline duration | Total slack | Free slack | Constraint | Baseline cost | Responsible | Involved | Text9 | Update Version | Sched Status | MHHS Resource Name | MHHS Programme Phase | RAG | Text29 | Milestone ID | Task Status | Artefact ID | Action | Tier |
| --- | --- | --- | --- | --- | --- | --- | --- | --- | --- | --- | --- | --- | --- | --- | --- | --- | --- | --- | --- | --- | --- | --- | --- | --- | --- | --- | --- | --- | --- | --- |
| 932 | 1.4.1.4.2.8.3 | **Cycle 3 Test data (SIT A) (2)** |  | 71d? | 2024-07-15 A | 2024-10-21 A |  | 100% |  | 2024-07-15 | 2024-10-21 | 41d |  |  |  | -0 | N/A | N/A | SIT | 5.4 | Overdue | N/A | Systems Integration Testing (SIT) | GREEN |  |  |  |  |  |  |
| 933 | 1.4.1.4.2.8.3.1 | Cycle 3 data requirments analysis - check Cycle 2 data for gaps Check blocked test cases |  | 10d? | 2024-07-15 A | 2024-07-26 A |  | 100% |  | 2024-07-15 | 2024-07-26 | 0d |  |  | finish no earlier than 2024-07-26 |  |  |  | SIT | 6.0 | Complete | Richard Puddephatt |  | COMPLETE | SITAG |  |  |  |  |  |
| 934 | 1.4.1.4.2.8.3.2 | Provide DCC with MPANS for deletion secure file with password |  | 1d? | 2024-08-12 A | 2024-08-12 A |  | 100% |  | 2024-08-12 | 2024-08-12 | 0d |  |  |  |  |  |  | SIT | 6.0 | Complete | Richard Puddephatt |  | COMPLETE |  |  |  |  |  |  |
| 935 | 1.4.1.4.2.8.3.3 | Receive MPANS from DCC to exclude |  | 1d? | 2024-08-09 A | 2024-08-09 A |  | 100% |  | 2024-08-09 | 2024-08-09 | 0d |  |  |  |  |  |  | SIT | 6.0 | Complete | Richard Puddephatt |  | COMPLETE |  |  |  |  |  |  |
| 936 | 1.4.1.4.2.8.3.4 | Exclude MPANS from allocation |  | 1d | 2024-08-16 A | 2024-08-16 A |  | 100% |  | 2024-08-16 | 2024-08-16 | 0d |  |  |  |  |  |  | SIT | 6.0 | Complete | Richard Puddephatt |  | COMPLETE |  |  |  |  |  |  |
| 937 | 1.4.1.4.2.8.3.5 | Allocate Cycle 3 MPANS |  | 16d? | 2024-08-06 A | 2024-08-27 A |  | 100% |  | 2024-08-06 | 2024-08-27 | 0d |  |  |  |  |  |  | SIT | 6.0 | Complete | Richard Puddephatt |  | COMPLETE |  |  |  |  |  |  |
| 938 | 1.4.1.4.2.8.3.6 | Generate Cycle 3 Data |  | 2d? | 2024-08-27 A | 2024-08-28 A |  | 100% |  | 2024-08-27 | 2024-08-28 | 0d |  |  |  |  |  |  | SIT | 6.0 | Complete | Richard Puddephatt |  | COMPLETE |  |  |  |  |  |  |
| 939 | 1.4.1.4.2.8.3.7 | Check data prior to sending to DCC |  | 5d? | 2024-08-22 A | 2024-08-28 A |  | 100% |  | 2024-08-22 | 2024-08-28 | 0d |  |  |  |  |  |  | SIT | 6.0 | Complete | Richard Puddephatt |  | COMPLETE |  |  |  |  |  |  |
| 940 | 1.4.1.4.2.8.3.8 | Share Cycle 3 MPAN data with DCC |  | 1d? | 2024-08-29 A | 2024-08-29 A |  | 100% |  | 2024-08-29 | 2024-08-29 | 0d |  |  |  |  |  |  | SIT | 6.0 | Complete | Richard Puddephatt |  | COMPLETE |  |  |  |  |  |  |
| 941 | 1.4.1.4.2.8.3.9 | DCC - load data and create registration Id's for Cycle 3 data |  | 13d? | 2024-08-27 A | 2024-09-12 A |  | 100% |  | 2024-08-27 | 2024-09-12 | 0d |  |  |  |  |  |  | SIT | 6.0 | Complete | Richard Puddephatt |  | COMPLETE |  |  |  |  |  |  |
| 942 | 1.4.1.4.2.8.3.10 | Add registration ID's to Cycle 3 Data |  | 2d? | 2024-09-12 A | 2024-09-13 A |  | 100% |  | 2024-09-12 | 2024-09-13 | 0d |  |  |  |  |  |  | SIT | 6.0 | Complete | Richard Puddephatt |  | COMPLETE |  |  |  |  |  |  |
| 943 | 1.4.1.4.2.8.3.11 | Share subset of data with St Cls for data load |  | 2d? | 2024-09-12 A | 2024-09-13 A |  | 100% |  | 2024-09-12 | 2024-09-13 | 0d |  |  |  |  |  |  | SIT | 6.0 | Complete | Richard Puddephatt |  | COMPLETE |  |  |  |  |  |  |
| 944 | 1.4.1.4.2.8.3.12 | St Clements to run test with Subset of data - MPRS business process checks including Import/Export MPANS |  | 5d? | 2024-09-16 A | 2024-09-20 A |  | 100% |  | 2024-09-16 | 2024-09-20 | 0d |  |  |  |  |  |  | SIT | 6.0 | Complete | Richard Puddephatt |  | COMPLETE |  |  |  |  |  |  |
| 945 | 1.4.1.4.2.8.3.13 | Send Cycle 3 data to partcipants for early sight of data |  | 3d? | 2024-09-25 A | 2024-09-27 A |  | 100% |  | 2024-09-25 | 2024-09-27 | 0d |  |  |  |  |  |  | SIT | 6.0 | Complete | Richard Puddephatt |  | COMPLETE |  |  |  |  |  |  |
| 946 | 1.4.1.4.2.8.3.14 | St Clements MPRS data load bulk files for Cycle 3 |  | 15d? | 2024-09-23 A | 2024-10-11 A |  | 100% |  | 2024-09-23 | 2024-10-11 | 0d |  |  |  |  |  |  | SIT | 6.0 | Complete | Richard Puddephatt |  | COMPLETE |  |  |  |  |  |  |
| 947 | 1.4.1.4.2.8.3.15 | New MPAN creation and load through DCC and St Clements |  | 1d? | 2024-10-11 A | 2024-10-11 A |  | 100% |  | 2024-10-11 | 2024-10-11 | 0d |  |  | start no earlier than 2024-10-11 |  |  |  | SIT | 6.0 | Complete | Richard Puddephatt |  | COMPLETE |  |  |  |  |  |  |
| 948 | 1.4.1.4.2.8.3.16 | Share files with PP's and central parties |  | 1d | 2024-10-11 A | 2024-10-11 A |  | 100% |  | 2024-10-11 | 2024-10-11 | 0d |  |  | start no earlier than 2024-10-11 |  |  |  | SIT | 6.0 | Complete | Richard Puddephatt |  | COMPLETE |  |  |  |  |  |  |
| 949 | 1.4.1.4.2.8.3.17 | Avanade to load data |  | 6d | 2024-10-14 A | 2024-10-21 A |  | 100% |  | 2024-10-14 | 2024-10-21 | 0d |  |  | start no earlier than 2024-10-14 |  |  |  | SIT | 6.0 | Complete | Richard Puddephatt |  | COMPLETE |  |  |  |  |  |  |
| 950 | 1.4.1.4.2.8.3.18 | Helix to load data |  | 6d | 2024-10-14 A | 2024-10-21 A |  | 100% |  | 2024-10-14 | 2024-10-21 | 0d |  |  | start no earlier than 2024-10-14 |  |  |  | SIT | 6.0 | Complete | Richard Puddephatt |  | COMPLETE |  |  |  |  |  |  |
| 951 | 1.4.1.4.2.8.3.19 | PP's and central parties to load all Cycle 3 data |  | 6d | 2024-10-14 A | 2024-10-21 A |  | 100% |  | 2024-10-14 | 2024-10-21 | 0d |  |  | start no earlier than 2024-10-14 |  |  |  | SIT | 6.0 | Complete | Richard Puddephatt |  | COMPLETE |  |  |  |  |  |  |
| 952 | 1.4.1.4.2.8.3.20 | All parties to finalise data load |  | 1d? | 2024-10-21 A | 2024-10-21 A |  | 100% |  | 2024-10-21 | 2024-10-21 | 0d |  |  | start no earlier than 2024-10-21 |  |  |  | SIT | 6.0 | Complete | Richard Puddephatt |  | COMPLETE |  | T3-TE-0081 |  |  |  |  |
| 953 | 1.4.1.4.2.8.4 | **Regression Test data (SIT A)** |  | 116d | 2024-10-28 A | 2025-04-07 |  | 4% | 111.3d | 2024-10-28 | 2025-04-07 | 45d | 34d |  |  | -0 | N/A | N/A | SIT | 5.4 |  | N/A | Systems Integration Testing (SIT) | GREEN |  |  |  |  |  |  |
| 954 | 1.4.1.4.2.8.4.1 | Prepare, Generate and Allocate Test Data |  | 94d | 2024-10-28 A | 2025-03-06 | 952FS+4d | 5% | 89.3d | 2024-10-28 | 2025-03-06 | 23d | 34d | 0d |  |  | SI Test Data |  | SIT | 5.14 | Green | Richard Puddephatt | Systems Integration Testing (SIT) | GREEN |  |  |  |  |  |  |
| 955 | 1.4.1.4.2.8.4.2 | Transmit Data Sets to PPs |  | 2d | 2025-03-07 | 2025-03-10 | 954 |  |  | 2025-03-07 | 2025-03-10 | 10d | 34d | 0d |  |  | SI Test Data |  | SIT | 5.14 | Green | Richard Puddephatt | Systems Integration Testing (SIT) | GREEN |  |  | 127.33 |  |  |  |
| 956 | 1.4.1.4.2.8.4.3 | PP's Iterative load and data integrity check |  | 20d | 2025-03-11 | 2025-04-07 | 955 |  |  | 2025-03-11 | 2025-04-07 | 5d | 34d | 0d |  |  | PP |  | SIT | 5.14 | Green | Richard Puddephatt | Systems Integration Testing (SIT) | GREEN |  |  | 131.33 |  |  |  |
| 957 | 1.4.1.4.2.8.4.4 | Regression - PP's confirmation that test data is ready for SIT Functional | milestone | 0d | 2025-04-07 | 2025-04-07 | 956 |  |  | 2025-04-07 | 2025-04-07 | 0d | 34d | 29d |  |  | SI Test Data |  | SIT | 5.14 | Green | Richard Puddephatt | Systems Integration Testing (SIT) | GREEN | SITAG | T3-TE-0082 | 158.71 | MHHS-ART140 MHHS-ART169 | 2/8 - added as a T3 milestone. Awaiting approval at TMAG | T3 |

Notes:
- 957: Forecasted dates are 04/04/25, which will be baselined once CR55 has been formally approved.

| ID | WBS | Task | Type | Duration | Start | Finish | Predecessors | Complete | Remaining | Baseline start | Baseline finish | Baseline duration | Baseline 1 start | Baseline 1 finish | Total slack | Constraint | Baseline cost | Responsible | Involved | Text9 | Update Version | MHHS Resource Name | MHHS Programme Phase | Sched Status | RAG | Milestone ID | Text29 | Tier | Artefact ID | Task Status |
| --- | --- | --- | --- | --- | --- | --- | --- | --- | --- | --- | --- | --- | --- | --- | --- | --- | --- | --- | --- | --- | --- | --- | --- | --- | --- | --- | --- | --- | --- | --- |
| 958 | 1.4.1.4.2.9 | **SIT Functional Test Readiness Report** |  | 45d | 2024-01-01 A | 2024-03-01 A |  | 100% |  | 2024-01-01 | 2024-03-01 | 44d | 2024-01-01 | 2024-02-23 |  |  | -0 | N/A | N/A | SIT | 5.0 | N/A | Systems Integration Testing (SIT) |  |  |  |  |  |  |  |
| 959 | 1.4.1.4.2.9.1 | **PP SIT Functional Test Readiness Report** |  | 44d | 2024-01-01 A | 2024-02-29 A |  | 100% |  | 2024-01-01 | 2024-02-29 | 44d | 2024-01-01 | 2024-02-09 |  |  | -0 | N/A | N/A | SIT | 5.0 | N/A | Systems Integration Testing (SIT) |  |  |  |  |  |  |  |
| 960 | 1.4.1.4.2.9.1.1 | Develop draft Test Readiness Report and submit to Programme for assurance |  | 21d | 2024-01-01 A | 2024-01-29 A |  | 100% |  | 2024-01-01 | 2024-01-29 | 20d | 2024-01-01 | 2024-01-29 |  | start no earlier than 2024-01-01 |  | PP | SI Test | SIT | 5.0 |  | Systems Integration Testing (SIT) | Complete | COMPLETE |  |  |  |  |  |
| 961 | 1.4.1.4.2.9.1.2 | Placing Reliance Stage 2 Review |  | 34d | 2024-01-15 A | 2024-02-29 A | 960SS+10d | 100% |  | 2024-01-15 | 2024-02-29 | 34d |  |  |  |  |  | SI Test | PP | SIT | 5.12 |  | Systems Integration Testing (SIT) | Complete | COMPLETE |  |  |  |  |  |
| 962 | 1.4.1.4.2.9.1.3 | Finalise Test Readiness Report and submit to Programme for assurance |  | 9d | 2024-01-30 A | 2024-02-09 A | 960 | 100% |  | 2024-01-30 | 2024-02-09 | 10d | 2024-01-29 | 2024-02-09 |  |  |  | PP | SI Test | SIT | 5.0 |  | Systems Integration Testing (SIT) | Complete | COMPLETE |  |  |  |  |  |
| 963 | 1.4.1.4.2.9.2 | **SI SIT Functional Test Readiness Report** |  | 40d | 2024-01-01 A | 2024-02-23 A |  | 100% |  | 2024-01-01 | 2024-02-23 | 40d | 2024-01-01 | 2024-02-23 |  |  |  | N/A | N/A | SIT | 5.0 | N/A | Systems Integration Testing (SIT) |  |  |  |  |  |  |  |
| 964 | 1.4.1.4.2.9.2.1 | Assure Test Participants' Test Readiness Reports |  | 35d | 2024-01-01 A | 2024-02-16 A | 960SS, 962FF+5d | 100% |  | 2024-01-01 | 2024-02-16 | 35d | 2024-01-01 | 2024-02-16 |  |  |  | SI Test | PP,IPA | SIT | 5.0 |  | Systems Integration Testing (SIT) | Complete | COMPLETE |  |  |  |  |  |
| 965 | 1.4.1.4.2.9.2.2 | Develop Overarching SIT Functional Test Readiness Report |  | 20d | 2024-01-22 A | 2024-02-16 A | 964FF | 100% |  | 2024-01-22 | 2024-02-16 | 20d | 2024-01-22 | 2024-02-16 |  |  |  | SI Test |  | SIT | 5.0 |  | Systems Integration Testing (SIT) | Complete | COMPLETE |  |  |  |  |  |
| 966 | 1.4.1.4.2.9.2.3 | Artefact review (via TMAG) and updates |  | 5d | 2024-02-19 A | 2024-02-23 A | 965 | 100% |  | 2024-02-19 | 2024-02-23 | 5d | 2024-02-19 | 2024-02-23 |  |  |  | SI Test | PP,IPA | SIT | 5.0 |  | Systems Integration Testing (SIT) | Complete | COMPLETE |  |  |  |  |  |
| 967 | 1.4.1.4.2.9.3 | SIT Functional Testing Preparation Complete | milestone | 0d | 2024-03-01 A | 2024-03-01 A | 966FF+5d, 833, 355, 961, 841, 848, 926 | 100% |  | 2024-03-01 | 2024-03-01 | 0d | 2024-03-01 | 2024-03-01 |  |  |  | SI Test | PP,IPA | SIT | 5.0 |  | Systems Integration Testing (SIT) | Complete | COMPLETE | T2-TE-0550 | SITAG | T2 |  |  |
| 968 | 1.4.1.4.3 | **SIT Migration Testing Preparation** |  | 560d? | 2022-10-31 A | 2024-12-20 |  | 92% | 45.32d? | 2022-10-31 | 2024-10-04 | 420d | 2022-11-16 | 2024-06-03 | 784d |  | -0 | N/A | N/A | SIT | 5.21 | N/A | Systems Integration Testing (SIT) |  |  |  |  |  |  |  |
| 969 | 1.4.1.4.3.1 | **Test Approach & Plan** |  | 75d | 2023-09-07 A | 2023-12-20 A |  | 100% |  | 2023-09-07 | 2023-12-20 | 75d | 2023-09-07 | 2023-12-20 |  |  | -0 | N/A | N/A | SIT | 5.0 |  | Systems Integration Testing (SIT) |  |  |  |  |  |  |  |
| 970 | 1.4.1.4.3.1.1 | Develop document with SITWG |  | 32d | 2023-09-07 A | 2023-10-20 A | 2280 | 100% |  | 2023-09-07 | 2023-10-20 | 25d | 2023-09-07 | 2023-10-11 |  | finish no earlier than 2023-10-11 |  | SI Test |  | SIT | 5.0 |  | Systems Integration Testing (SIT) | Complete | COMPLETE |  |  |  |  |  |
| 971 | 1.4.1.4.3.1.2 | Draft document review with Code Bodies |  | 8d | 2023-10-23 A | 2023-11-01 A | 970 | 100% |  | 2023-10-23 | 2023-11-01 | 10d | 2023-10-12 | 2023-10-25 |  |  |  | SI Test | Code Bodies | SIT | 5.0 |  | Systems Integration Testing (SIT) | Complete | COMPLETE |  |  |  |  |  |
| 972 | 1.4.1.4.3.1.3 | Industry Consultation |  | 10d | 2023-11-02 A | 2023-11-15 A | 971 | 100% |  | 2023-11-02 | 2023-11-15 | 10d |  |  |  |  |  | PP |  | SIT | 5.1 |  | Systems Integration Testing (SIT) | Complete | COMPLETE |  |  |  |  |  |
| 973 | 1.4.1.4.3.1.4 | Artefact review (via TMAG) and updates |  | 25d | 2023-11-16 A | 2023-12-20 A | 972 | 100% |  | 2023-11-16 | 2023-12-20 | 30d | 2023-10-26 | 2023-12-20 |  |  |  | SI Test | PP,IPA,Code Bodies | SIT | 5.0 |  | Systems Integration Testing (SIT) | Complete | COMPLETE |  |  |  |  |  |
| 974 | 1.4.1.4.3.1.5 | SIT Migration Testing Test Approach & Plan approved | milestone | 0d | 2023-12-20 A | 2023-12-20 A | 973 | 100% |  | 2023-12-20 | 2023-12-20 | 1d | 2023-12-20 | 2023-12-20 |  | finish no earlier than 2023-12-20 |  | SI Test | PP | SIT | 5.14 |  | Systems Integration Testing (SIT) | Complete | COMPLETE | T3-TE-0018 | SITAG | T3 | MHHS-ART073 |  |
| 975 | 1.4.1.4.3.2 | **Test Data Approach & Plan** |  | 35d | 2023-11-02 A | 2023-12-20 A |  | 100% |  | 2023-11-02 | 2023-12-20 | 35d | 2023-10-26 | 2023-12-20 |  |  | -0 | N/A | N/A | SIT | 5.0 | N/A | Systems Integration Testing (SIT) |  |  |  |  |  |  |  |
| 976 | 1.4.1.4.3.2.1 | Industry Consultation |  | 10d | 2023-11-02 A | 2023-11-15 A | 972SS | 100% |  | 2023-11-02 | 2023-11-15 | 10d |  |  |  |  |  | PP |  | SIT | 5.1 | PP | Systems Integration Testing (SIT) | Complete | COMPLETE |  |  |  |  |  |
| 977 | 1.4.1.4.3.2.2 | Artefact review (via TMAG) and updates |  | 25d | 2023-11-16 A | 2023-12-20 A | 976 | 100% |  | 2023-11-16 | 2023-12-20 | 30d | 2023-10-26 | 2023-12-20 |  |  |  | SI Test Data |  | SIT | 5.0 | Richard Puddephatt | Systems Integration Testing (SIT) | Complete | COMPLETE |  |  |  |  |  |
| 978 | 1.4.1.4.3.2.3 | SIT Migration Test Data Test Approach & Plan approved | milestone | 0d | 2023-12-20 A | 2023-12-20 A | 977 | 100% |  | 2023-12-20 | 2023-12-20 | 0d | 2023-12-20 | 2023-12-20 |  |  |  | SI Test Data | PP,IPA | SIT | 5.14 | Richard Puddephatt | Systems Integration Testing (SIT) | Complete | COMPLETE |  |  |  |  |  |
| 979 | 1.4.1.4.3.3 | **Test scenarios & Test Cases** |  | 262d? | 2023-12-21 A | 2024-12-20 |  | 73% | 70.63d? | 2023-12-21 | 2024-10-04 | 65d | 2023-07-24 | 2024-01-17 | 784d |  | -0 | N/A | N/A | SIT | 5.16 | N/A | Systems Integration Testing (SIT) |  |  |  |  |  |  |  |
| 980 | 1.4.1.4.3.3.1 | **Theme 1** |  | 65d | 2023-12-21 A | 2024-03-20 A |  | 100% |  | 2023-12-21 | 2024-03-20 | 65d |  |  |  |  | -0 | N/A | N/A | SIT | 5.16 | N/A | Systems Integration Testing (SIT) |  |  |  |  |  |  | -448.67 |
| 981 | 1.4.1.4.3.3.1.1 | Develop Test Scenarios & Test Cases |  | 25d | 2023-12-21 A | 2024-01-24 A | 974 | 100% |  | 2023-12-21 | 2024-01-24 | 25d |  |  |  |  |  | SI Test | SI Test, PP | SIT | 5.16 |  |  | Complete | COMPLETE |  |  |  |  |  |
| 982 | 1.4.1.4.3.3.1.2 | Industry Review Workshop |  | 1d | 2024-01-25 A | 2024-01-25 A | 981 | 100% |  | 2024-01-25 | 2024-01-25 | 1d |  |  |  |  |  | SI Test, PP | SI Test, PP | SIT | 5.16 |  |  | Complete | COMPLETE |  |  |  |  |  |
| 983 | 1.4.1.4.3.3.1.3 | Industry Consultation Review |  | 6d | 2024-02-05 A | 2024-02-12 A | 982FS+6d | 100% |  | 2024-02-05 | 2024-02-12 | 6d |  |  |  |  |  | SI Test, PP | SI Test, PP | SIT | 5.16 |  |  | Complete | COMPLETE |  |  |  |  |  |
| 984 | 1.4.1.4.3.3.1.4 | Review with SIT Working Group |  | 5d | 2024-02-29 A | 2024-03-06 A | 983FS+12d | 100% |  | 2024-02-29 | 2024-03-06 | 5d |  |  |  |  |  | SI Test, PP | SI Test, PP | SIT | 5.19 |  |  | Complete | COMPLETE |  |  |  |  |  |
| 985 | 1.4.1.4.3.3.1.5 | SIT Migration Test scenarios & Test Cases Approved - Theme 1 | milestone | 0d | 2024-03-20 A | 2024-03-20 A | 984FS+10d | 100% |  | 2024-03-20 | 2024-03-20 | 0d |  |  |  |  |  | SI Test | SI Test, PP | SIT | 5.21 |  | Systems Integration Testing (SIT) | Complete | COMPLETE | T3-TE-0110 | SITAG |  |  |  |

| ID | WBS | Task | Type | Duration | Start | Finish | Predecessors | Complete | Remaining | Baseline start | Baseline finish | Baseline duration | Total slack | Free slack | Constraint | Baseline cost | Responsible | Involved | Text9 | Task Status | Update Version | MHHS Resource Name | MHHS Programme Phase | Sched Status | RAG | Milestone ID | Text29 |
| --- | --- | --- | --- | --- | --- | --- | --- | --- | --- | --- | --- | --- | --- | --- | --- | --- | --- | --- | --- | --- | --- | --- | --- | --- | --- | --- | --- |
| 986 | 1.4.1.4.3.3.2 | **Theme 2** |  | 85d | 2023-12-21 A | 2024-04-17 A |  | 100% |  | 2023-12-21 | 2024-04-17 | 85d |  |  |  | -0 | N/A | N/A | SIT | -448.67 | 5.16 | N/A | Systems Integration Testing (SIT) |  |  |  |  |
| 987 | 1.4.1.4.3.3.2.1 | Develop Test Scenarios & Test Cases |  | 40d | 2023-12-21 A | 2024-02-14 A | 974 | 100% |  | 2023-12-21 | 2024-02-14 | 40d |  |  |  |  | SI Test | SI Test, PP | SIT |  | 5.16 |  |  | Complete | COMPLETE |  |  |
| 988 | 1.4.1.4.3.3.2.2 | Industry Review Workshop |  | 1d | 2024-02-15 A | 2024-02-15 A | 987 | 100% |  | 2024-02-15 | 2024-02-15 | 1d |  |  |  |  | SI Test, PP | SI Test, PP | SIT |  | 5.16 |  |  | Complete | COMPLETE |  |  |
| 989 | 1.4.1.4.3.3.2.3 | Industry Consultation Review |  | 6d | 2024-02-26 A | 2024-03-04 A | 988FS+6d | 100% |  | 2024-02-26 | 2024-03-04 | 6d |  |  |  |  | SI Test, PP | SI Test, PP | SIT |  | 5.19 |  |  | Complete | COMPLETE |  |  |
| 990 | 1.4.1.4.3.3.2.4 | Review with SIT Working Group |  | 5d | 2024-03-28 A | 2024-04-03 A | 989FS+17d | 100% |  | 2024-03-28 | 2024-04-03 | 5d |  |  |  |  | SI Test, PP | SI Test, PP | SIT |  | 5.16 |  |  | Complete | COMPLETE |  |  |
| 991 | 1.4.1.4.3.3.2.5 | SIT Migration Test scenarios & Test Cases Approved - Theme 2 | milestone | 0d | 2024-04-17 A | 2024-04-17 A | 990FS+10d | 100% |  | 2024-04-17 | 2024-04-17 | 0d |  |  |  |  | SI Test | SI Test, PP | SIT |  | 5.22 |  | Systems Integration Testing (SIT) | Complete | COMPLETE | T3-TE-0111 | SITAG |
| 992 | 1.4.1.4.3.3.3 | **Theme 3** |  | 85d | 2023-12-21 A | 2024-04-17 A |  | 100% |  | 2023-12-21 | 2024-04-17 | 85d |  |  |  | -0 | N/A | N/A | SIT | -448.67 | 5.16 | N/A | Systems Integration Testing (SIT) |  |  |  |  |
| 993 | 1.4.1.4.3.3.3.1 | Develop Test Scenarios & Test Cases |  | 55d | 2023-12-21 A | 2024-03-06 A | 974 | 100% |  | 2023-12-21 | 2024-03-06 | 55d |  |  |  |  | SI Test | SI Test, PP | SIT |  | 5.19 |  |  | Complete | COMPLETE |  |  |
| 994 | 1.4.1.4.3.3.3.2 | Industry Review Workshop |  | 1d | 2024-03-07 A | 2024-03-07 A | 993 | 100% |  | 2024-03-07 | 2024-03-07 | 1d |  |  |  |  | SI Test, PP | SI Test, PP | SIT |  | 5.16 |  |  | Complete | COMPLETE |  |  |
| 995 | 1.4.1.4.3.3.3.3 | Industry Consultation Review |  | 6d | 2024-03-13 A | 2024-03-20 A | 994FS+3d | 100% |  | 2024-03-13 | 2024-03-20 | 6d |  |  |  |  | SI Test, PP | SI Test, PP | SIT |  | 5.16 |  |  | Complete | COMPLETE |  |  |
| 996 | 1.4.1.4.3.3.3.4 | Review with SIT Working Group |  | 5d | 2024-03-28 A | 2024-04-03 A | 995FS+5d | 100% |  | 2024-03-28 | 2024-04-03 | 5d |  |  |  |  | SI Test, PP | SI Test, PP | SIT |  | 5.16 |  |  | Complete | COMPLETE |  |  |
| 997 | 1.4.1.4.3.3.3.5 | SIT Migration Test scenarios & Test Cases Approved - Theme 3 | milestone | 0d | 2024-04-17 A | 2024-04-17 A | 996FS+10d | 100% |  | 2024-04-17 | 2024-04-17 | 0d |  |  |  |  | SI Test | SI Test, PP | SIT |  | 5.22 |  | Systems Integration Testing (SIT) | Complete | COMPLETE | T3-TE-0112 | SITAG |
| 998 | 1.4.1.4.3.3.4 | **RTTM Development** |  | 27d? | 2024-08-29 A | 2024-10-04 |  | 84% | 4.38d? | 2024-08-29 | 2024-10-04 | 0d | 839d |  |  |  |  |  | SIT | -693.67 | 6.0 |  |  | Overdue Start | GREEN |  |  |
| 999 | 1.4.1.4.3.3.4.1 | Develop Manual SIT Migration RTTM |  | 17d | 2024-08-29 A | 2024-09-20 A |  | 100% |  | 2024-08-29 | 2024-09-20 | 0d |  |  | start no earlier than 2024-08-29 |  |  |  | SIT |  | 6.0 |  |  | Complete | COMPLETE |  |  |
| 1000 | 1.4.1.4.3.3.4.2 | Manual SIT Migration RTTM Complete | milestone | 0d | 2024-09-20 A | 2024-09-20 A | 999 | 100% |  | 2024-09-20 | 2024-09-20 | 0d |  |  |  |  |  |  | SIT |  | 6.0 |  |  | Complete | COMPLETE |  |  |
| 1001 | 1.4.1.4.3.3.4.3 | Develop Automated SIT Migration RTTM |  | 20d | 2024-09-09 A | 2024-10-04 |  | 70% | 6d | 2024-09-09 | 2024-10-04 | 0d | 839d | 0d | start no earlier than 2024-09-09 |  |  |  | SIT |  | 6.0 |  |  | Overdue | RED |  |  |
| 1002 | 1.4.1.4.3.3.4.4 | Automated SIT Migration RTTM Complete | milestone | 0d? | 2024-10-04 | 2024-10-04 | 1001 |  |  | 2024-10-04 | 2024-10-04 | 0d | 839d |  |  |  |  |  | SIT | -26.29 | 6.0 |  |  | Overdue Start | RED |  |  |
| 1003 | 1.4.1.4.3.3.5 | **Gap analysis** |  | 72d? | 2024-09-12 A | 2024-12-20 |  | 30% | 50.67d? | 2024-09-12 | 2024-10-04 | 0d | 784d |  |  |  |  |  | SIT | -693.67 | 6.0 |  |  | Overdue Start | GREEN |  |  |
| 1004 | 1.4.1.4.3.3.5.1 | Identify gaps in test case coverage following RTTM review. |  | 12d | 2024-09-12 A | 2024-09-27 A | 999SS+10d | 100% |  | 2024-09-12 | 2024-09-27 | 0d |  |  |  |  |  |  | SIT |  | 6.0 |  |  | Complete | COMPLETE |  |  |
| 1005 | 1.4.1.4.3.3.5.2 | Address gaps in test case coverage following RTTM review. |  | 17d | 2024-09-19 A | 2024-10-11 | 1004SS+5d | 14% | 14.6d | 2024-09-19 | 2024-10-04 | 0d | 834d |  |  |  |  |  | SIT |  | 6.0 |  |  | Overdue | RED |  |  |
| 1006 | 1.4.1.4.3.3.5.3 | Gap analysis complete | milestone | 0d? | 2024-10-11 A | 2024-10-11 A | 1005 | 100% |  | 2024-10-04 | 2024-10-04 | 0d |  |  |  |  |  |  | SIT |  | 6.0 |  |  | Complete | COMPLETE |  |  |
| 1007 | 1.4.1.4.3.3.5.4 | Test Script updates identified |  | 1d? | 2024-10-14 A | 2024-10-14 A | 1006 | 100% |  | 2024-10-14 | 2024-10-14 | 0d |  |  |  |  |  |  | SIT |  | 6.11 |  |  | Complete | COMPLETE |  |  |
| 1008 | 1.4.1.4.3.3.5.5 | Test Scripts updates |  | 16d? | 2024-10-14 A | 2024-11-04 A | 1007FS-1d | 100% |  | 2024-10-14 | 2024-11-04 | 0d |  |  |  |  |  |  | SIT |  | 6.11 |  |  | Complete | COMPLETE |  |  |
| 1009 | 1.4.1.4.3.3.5.6 | RTTM Updated |  | 1d? | 2024-10-29 | 2024-10-29 | 1008FS-5d |  |  | 2024-10-29 | 2024-10-29 | 0d | 822d |  |  |  |  |  | SIT | -1.67 | 6.11 |  |  | Green | GREEN |  |  |
| 1010 | 1.4.1.4.3.3.5.7 | Removal of de-scoped TCs from the RTTMs |  | 2d | 2024-10-31 | 2024-11-01 | 1008FS-3d |  |  | 2024-10-31 | 2024-11-01 | 0d | 819d |  |  |  |  |  | SIT | 0.33 | 6.11 |  |  | Green | GREEN |  |  |
| 1011 | 1.4.1.4.3.3.5.8 | Update and stabilisation of all TC ADO IDs |  | 2d | 2024-10-31 | 2024-11-01 | 1008FS-3d |  |  | 2024-10-31 | 2024-11-01 | 0d | 819d |  |  |  |  |  | SIT | 0.33 | 6.11 |  |  | Green | GREEN |  |  |
| 1012 | 1.4.1.4.3.3.5.9 | Addition and integration of Role tags to reqs in the Role RTTMs |  | 3d | 2024-10-30 | 2024-11-01 | 1008FS-4d |  |  | 2024-10-30 | 2024-11-01 | 0d | 819d |  |  |  |  |  | SIT | -0.67 | 6.11 |  |  | Green | GREEN |  |  |
| 1013 | 1.4.1.4.3.3.5.10 | Update of the RTTM All sheet (porting of the individual RTTMs) |  | 2d | 2024-10-31 | 2024-11-01 | 1008FS-3d |  |  | 2024-10-31 | 2024-11-01 | 0d | 784d | 0d |  |  |  |  | SIT | 0.33 | 6.11 |  |  | Green | GREEN |  |  |
| 1014 | 1.4.1.4.3.3.5.11 | ADO IDs corrected |  | 1d? | 2024-11-04 | 2024-11-04 | 1013 |  |  | 2024-11-04 | 2024-11-04 | 0d | 784d | 0d | start no earlier than 2024-10-16 |  |  |  | SIT | 4.33 | 6.11 |  |  | Green | GREEN |  |  |
| 1015 | 1.4.1.4.3.3.5.12 | Migration RTTM ready for import into ADO | milestone | 0d | 2024-11-04 | 2024-11-04 | 1014 |  |  | 2024-11-04 | 2024-11-04 | 0d | 784d | 0d |  |  |  |  | SIT | 4.71 | 6.11 |  |  | Green | GREEN |  |  |
| 1016 | 1.4.1.4.3.3.5.13 | Issue Static RTTM to Code Bodies |  | 1d? | 2024-11-05 | 2024-11-05 | 1015 |  |  | 2024-11-05 | 2024-11-05 | 0d | 784d | 0d |  |  |  |  | SIT | 5.33 | 6.11 |  |  | Green | GREEN |  |  |
| 1017 | 1.4.1.4.3.3.5.14 | Code Body Acceptance of RTTM |  | 6d | 2024-11-06 | 2024-11-13 | 1016 |  |  | 2024-11-06 | 2024-11-13 | 0d | 784d | 0d |  |  |  |  | SIT | 6.33 | 6.11 |  |  | Green | GREEN |  |  |

Notes:
- 1016: 22/10/24 - New milestone?

| ID | WBS | Task | Type | Duration | Start | Finish | Predecessors | Baseline start | Baseline finish | Total slack | Free slack | Constraint | Text9 | Task Status | Update Version | Sched Status | RAG |
| --- | --- | --- | --- | --- | --- | --- | --- | --- | --- | --- | --- | --- | --- | --- | --- | --- | --- |
| 1018 | 1.4.1.4.3.3.5.15 | **ADO Clean-up** |  | 17d? | 2024-10-24 | 2024-11-15 |  | 2024-10-24 | 2024-11-15 |  |  |  | SIT | -727.67 | 6.11 | Overdue Start | RED |
| 1019 | 1.4.1.4.3.3.5.15.1 | Theme alignment |  | 1d? | 2024-10-28 | 2024-10-28 |  | 2024-10-28 | 2024-10-28 | 823d |  | start no earlier than 2024-10-28 | SIT | -2.67 | 6.11 | Green | GREEN |
| 1020 | 1.4.1.4.3.3.5.15.2 | Understand Additional suffix Fields in ADO as defined by Kevin |  | 1d? | 2024-10-25 | 2024-10-25 |  | 2024-10-25 | 2024-10-25 | 824d |  | finish no earlier than 2024-10-25 | SIT | -5.67 | 6.11 | Green | GREEN |
| 1021 | 1.4.1.4.3.3.5.15.3 | Correct Missing Test Case References |  | 1d? | 2024-10-28 | 2024-10-28 |  | 2024-10-28 | 2024-10-28 | 823d |  | start no earlier than 2024-10-28 | SIT | -2.67 | 6.11 | Green | GREEN |
| 1022 | 1.4.1.4.3.3.5.15.4 | Load Functional RTTMs into ADO |  | 1d? | 2024-10-28 | 2024-10-28 |  | 2024-10-28 | 2024-10-28 | 823d |  | start no earlier than 2024-10-28 | SIT | -2.67 | 6.11 | Green | GREEN |
| 1023 | 1.4.1.4.3.3.5.15.5 | Load Migration RTTMs into ADO |  | 1d? | 2024-11-06 | 2024-11-06 |  | 2024-11-06 | 2024-11-06 | 816d |  | start no earlier than 2024-11-06 | SIT | 6.33 | 6.11 | Green | GREEN |
| 1024 | 1.4.1.4.3.3.5.15.6 | Confirm Missing fields in ADO are resolved |  | 1d? | 2024-11-07 | 2024-11-07 |  | 2024-11-07 | 2024-11-07 | 815d |  | finish no earlier than 2024-11-07 | SIT | 7.33 | 6.11 | Green | GREEN |
| 1025 | 1.4.1.4.3.3.5.15.7 | Reload Functional RTTM into ADO |  | 1d? | 2024-11-07 | 2024-11-07 |  | 2024-11-07 | 2024-11-07 | 815d |  | start no earlier than 2024-11-07 | SIT | 7.33 | 6.11 | Green | GREEN |
| 1026 | 1.4.1.4.3.3.5.15.8 | **ADO Design Documentation** |  | 10d? | 2024-11-04 | 2024-11-15 |  | 2024-11-04 | 2024-11-15 |  |  |  | SIT | -727.67 | 6.11 | Overdue Start | RED |
| 1027 | 1.4.1.4.3.3.5.15.8.1 | Produce ADO high Level Design and Data Model |  | 1d? | 2024-11-15 | 2024-11-15 |  | 2024-11-15 | 2024-11-15 | 809d |  | finish no earlier than 2024-11-15 | SIT | 15.33 | 6.11 | Green | GREEN |
| 1028 | 1.4.1.4.3.3.5.15.8.2 | Produce Report derivation document |  | 1d? | 2024-11-15 | 2024-11-15 |  | 2024-11-15 | 2024-11-15 | 809d |  | finish no earlier than 2024-11-15 | SIT | 15.33 | 6.11 | Green | GREEN |
| 1029 | 1.4.1.4.3.3.5.16 | **Test Case Rationalisation (Fuctional + Migration)** |  | 32d | 2024-11-07 | 2024-12-20 |  | 2024-11-07 | 2024-12-20 | 784d |  |  | SIT | -727.67 | 6.11 | Overdue Start | RED |
| 1030 | 1.4.1.4.3.3.5.16.1 | Internal preliminary rationalisation workshop 1 |  | 1d | 2024-11-07 | 2024-11-07 | 1016FS+1d | 2024-11-07 | 2024-11-07 | 815d |  |  | SIT | 7.33 | 6.11 | Green | GREEN |
| 1031 | 1.4.1.4.3.3.5.16.2 | Baseline RTTMs | milestone | 0d | 2024-11-13 | 2024-11-13 | 1017 | 2024-11-13 | 2024-11-13 | 811d |  |  | SIT | 13.71 | 6.11 | Green | GREEN |
| 1032 | 1.4.1.4.3.3.5.16.3 | Baseline test cases | milestone | 0d | 2024-11-13 | 2024-11-13 | 1017 | 2024-11-13 | 2024-11-13 | 784d | 0d |  | SIT | 13.71 | 6.11 | Green | GREEN |
| 1033 | 1.4.1.4.3.3.5.16.4 | Produce requirements / test case analysis |  | 1d | 2024-11-14 | 2024-11-14 | 1032 | 2024-11-14 | 2024-11-14 | 784d | 0d |  | SIT | 14.33 | 6.11 | Green | GREEN |
| 1034 | 1.4.1.4.3.3.5.16.5 | Internal finalisation rationalisation workshop 2 |  | 1d | 2024-11-15 | 2024-11-15 | 1033 | 2024-11-15 | 2024-11-15 | 784d | 0d |  | SIT | 15.33 | 6.11 | Green | GREEN |
| 1035 | 1.4.1.4.3.3.5.16.6 | SRO walkthrough |  | 1d | 2024-11-21 | 2024-11-21 | 1034FS+3d | 2024-11-21 | 2024-11-21 | 784d | 0d |  | SIT | 21.33 | 6.11 | Green | GREEN |
| 1036 | 1.4.1.4.3.3.5.16.7 | Code Bodies walkthrough |  | 1d | 2024-11-26 | 2024-11-26 | 1035FS+2d | 2024-11-26 | 2024-11-26 | 784d | 0d |  | SIT | 26.33 | 6.11 | Green | GREEN |
| 1037 | 1.4.1.4.3.3.5.16.8 | Send invites to PPs for walkthrough |  | 1d | 2024-11-26 | 2024-11-26 | 1036FS-1d | 2024-11-26 | 2024-11-26 | 784d | 0d |  |  | 26.33 | 6.11 | Green | GREEN |
| 1038 | 1.4.1.4.3.3.5.16.9 | PP walkthrough |  | 1d | 2024-12-03 | 2024-12-03 | 1037FS+4d | 2024-12-03 | 2024-12-03 | 784d | 0d |  | SIT | 33.33 | 6.11 | Green | GREEN |
| 1039 | 1.4.1.4.3.3.5.16.10 | Update test cases |  | 5d | 2024-12-04 | 2024-12-10 | 1038 | 2024-12-04 | 2024-12-10 | 792d |  |  | SIT | 34.33 | 6.11 | Green | GREEN |
| 1040 | 1.4.1.4.3.3.5.16.11 | Update RTTM |  | 5d | 2024-12-04 | 2024-12-10 | 1038 | 2024-12-04 | 2024-12-10 | 792d |  |  | SIT | 34.33 | 6.11 | Green | GREEN |
| 1041 | 1.4.1.4.3.3.5.16.12 | Update master test case spreadsheet |  | 5d | 2024-12-04 | 2024-12-10 | 1038 | 2024-12-04 | 2024-12-10 | 784d | 0d |  | SIT | 34.33 | 6.11 | Green | GREEN |
| 1042 | 1.4.1.4.3.3.5.16.13 | Issue to SITAG |  | 1d | 2024-12-11 | 2024-12-11 | 1041 | 2024-12-11 | 2024-12-11 | 784d | 0d |  | SIT | 41.33 | 6.11 | Green | GREEN |
| 1043 | 1.4.1.4.3.3.5.16.14 | Prepare ADO update |  | 6d | 2024-12-11 | 2024-12-18 | 1041 | 2024-12-11 | 2024-12-18 | 786d |  |  |  | 41.33 | 6.11 | Green | GREEN |
| 1044 | 1.4.1.4.3.3.5.16.15 | Sign off by SITAG | milestone | 0d | 2024-12-18 | 2024-12-18 | 1042FS+5d | 2024-12-18 | 2024-12-18 | 784d | 0d |  |  | 48.71 | 6.11 | Green | GREEN |
| 1045 | 1.4.1.4.3.3.5.16.16 | Update ADO |  | 2d | 2024-12-19 | 2024-12-20 | 1044 | 2024-12-19 | 2024-12-20 | 784d | 0d |  | SIT | 49.33 | 6.11 | Green | GREEN |
| 1046 | 1.4.1.4.3.3.5.16.17 | Update all ADO reporting |  | 2d | 2024-12-19 | 2024-12-20 | 1044 | 2024-12-19 | 2024-12-20 | 784d | 0d |  | SIT | 49.33 | 6.11 | Green | GREEN |
| 1047 | 1.4.1.4.3.3.5.16.18 | Test Case Rationalisation complete | milestone | 0d | 2024-12-20 | 2024-12-20 | 1045, 1046 | 2024-12-20 | 2024-12-20 | 784d |  |  | SIT | 50.71 | 6.11 | Green | GREEN |

| ID | WBS | Task | Type | Duration | Start | Finish | Predecessors | Complete | Remaining | Baseline start | Baseline finish | Baseline duration | Baseline 1 start | Baseline 1 finish | Total slack | Constraint | Baseline cost | Responsible | Involved | Text9 | Update Version | MHHS Resource Name | MHHS Programme Phase | Sched Status | RAG | Milestone ID | Text29 | Tier | Artefact ID | Guidance |
| --- | --- | --- | --- | --- | --- | --- | --- | --- | --- | --- | --- | --- | --- | --- | --- | --- | --- | --- | --- | --- | --- | --- | --- | --- | --- | --- | --- | --- | --- | --- |
| 1048 | 1.4.1.4.3.4 | **Environments (SIT B)** |  | 435d | 2022-10-31 A | 2024-06-28 A |  | 100% |  | 2022-10-31 | 2024-06-28 | 420d | 2022-11-16 | 2024-05-13 |  |  | -0 | N/A | N/A | SIT | 5.0 | N/A | Systems Integration Testing (SIT) |  |  |  |  |  |  |  |
| 1049 | 1.4.1.4.3.4.1 | **PP Environments (SIT B)** |  | 41d | 2024-05-03 A | 2024-06-28 A |  | 100% |  | 2024-05-03 | 2024-06-28 | 26d | 2022-11-16 | 2024-05-13 |  |  | -0 | N/A | N/A | SIT | 5.0 | N/A | Systems Integration Testing (SIT) |  |  |  |  |  |  |  |
| 1050 | 1.4.1.4.3.4.1.1 | PP Environments available | milestone | 0d | 2024-05-03 A | 2024-05-03 A | 508 | 100% |  | 2024-05-03 | 2024-05-03 | 0d | 2022-11-16 | 2024-04-01 |  | start no earlier than 2024-05-03 |  | PP | SI Test | SIT | 5.21 | Simon Berry | Systems Integration Testing (SIT) | Complete | COMPLETE |  |  |  |  |  |
| 1051 | 1.4.1.4.3.4.1.2 | PP Onboarding / Smoke test |  | 35d | 2024-05-13 A | 2024-06-28 A | 1050FS+6d | 100% |  | 2024-05-13 | 2024-06-28 | 20d | 2022-11-16 | 2024-04-01 |  |  |  | PP | SI Test | SIT | 5.21 | Simon Berry | Systems Integration Testing (SIT) | Complete | COMPLETE |  |  |  |  |  |
| 1052 | 1.4.1.4.3.4.1.3 | DTN Connectivity Proving Complete |  | 5d | 2024-06-10 A | 2024-06-14 A | 1050FS+26d | 100% |  | 2024-06-10 | 2024-06-14 | 0d | 2024-04-15 | 2024-04-26 |  |  |  | PP | SI Test | SIT | 5.21 | Simon Berry | Systems Integration Testing (SIT) | Complete | COMPLETE |  |  |  |  |  |
| 1053 | 1.4.1.4.3.4.1.4 | PP Code Deployment | milestone | 0d | 2024-06-14 A | 2024-06-14 A | 1052 | 100% |  | 2024-06-14 | 2024-06-14 | 0d | 2024-04-29 | 2024-05-13 |  |  |  | PP | SI Test | SIT | 5.21 | Simon Berry | Systems Integration Testing (SIT) | Complete | COMPLETE |  |  |  |  |  |
| 1054 | 1.4.1.4.3.4.2 | **SI Environments (SIT B)** |  | 425d | 2022-10-31 A | 2024-06-14 A |  | 100% |  | 2022-10-31 | 2024-06-14 | 420d | 2022-11-16 | 2024-05-10 |  |  | -0 | N/A | N/A | SIT | 5.0 | N/A | Systems Integration Testing (SIT) |  |  |  |  |  |  |  |
| 1055 | 1.4.1.4.3.4.2.1 | Coordinate SIT Participants' SIT B environment preparation |  | 420d | 2022-10-31 A | 2024-06-07 A |  | 100% |  | 2022-10-31 | 2024-06-07 | 420d | 2022-11-16 | 2024-04-01 |  |  |  | SI Test | PP | SIT | 5.21 | Simon Berry | Systems Integration Testing (SIT) | Complete | COMPLETE |  |  |  |  |  |
| 1056 | 1.4.1.4.3.4.2.2 | Assure PPs' self-declaration of environment preparation complete (incl. security certificates and security compliance) | milestone | 0d | 2024-06-07 A | 2024-06-07 A | 1055 | 100% |  | 2024-06-07 | 2024-06-07 | 0d | 2022-11-16 | 2024-03-29 |  |  |  | SI Test | PP | SIT | 5.21 | Simon Berry | Systems Integration Testing (SIT) | Complete | COMPLETE |  |  |  |  |  |
| 1057 | 1.4.1.4.3.4.2.3 | SIT Participants' SIT B environments ready to start connectivity proving (incl. certificates and security compliance) | milestone | 0d | 2024-06-05 A | 2024-06-05 A | 1050FS+24d | 100% |  | 2024-06-05 | 2024-06-05 | 0d | 2024-04-01 | 2024-04-01 |  |  |  | SI Test | PP,IPA | SIT | 5.26 | Simon Berry | Systems Integration Testing (SIT) | Complete | COMPLETE | T3-TE-0033 | SITAG | T3 |  |  |
| 1058 | 1.4.1.4.3.4.2.4 | Coordinate SIT Participants' SIT B environment connectivity proving |  | 2d | 2024-06-06 A | 2024-06-07 A | 1057 | 100% |  | 2024-06-06 | 2024-06-07 | 19d | 2024-04-01 | 2024-04-26 |  |  |  | SI Test | PP | SIT | 5.21 | Simon Berry | Systems Integration Testing (SIT) | Complete | COMPLETE |  |  |  |  |  |
| 1059 | 1.4.1.4.3.4.2.5 | Coordinate deployment of MHHS solution code to SIT Participants' SIT B environments | milestone | 0d | 2024-06-14 A | 2024-06-14 A | 1053 | 100% |  | 2024-06-14 | 2024-06-14 | 4d | 2024-04-15 | 2024-04-26 |  |  |  | SI Test | PP | SIT | 5.21 | Simon Berry | Systems Integration Testing (SIT) | Complete | COMPLETE |  |  |  |  |  |
| 1060 | 1.4.1.4.3.5 | **SIT Migration Test Readiness Report** |  | 44d | 2024-04-02 A | 2024-05-31 A |  | 100% |  | 2024-04-02 | 2024-05-31 | 44d | 2024-04-02 | 2024-05-27 |  |  | -0 | N/A | N/A | SIT | 5.0 | N/A | Systems Integration Testing (SIT) |  |  |  |  |  |  |  |
| 1061 | 1.4.1.4.3.5.1 | **PP SIT Migration Test Readiness Report** |  | 44d | 2024-04-02 A | 2024-05-31 A |  | 100% |  | 2024-04-02 | 2024-05-31 | 44d | 2024-04-02 | 2024-05-13 |  |  | -0 | N/A | N/A | SIT | 5.0 | N/A | Systems Integration Testing (SIT) |  |  |  |  |  |  |  |
| 1062 | 1.4.1.4.3.5.1.1 | Develop draft Test Readiness Report and submit to Programme for assurance |  | 20d | 2024-04-02 A | 2024-04-29 A |  | 100% |  | 2024-04-02 | 2024-04-29 | 20d | 2024-04-02 | 2024-04-30 |  | start no earlier than 2024-04-02 |  | PP | SI Test | SIT | 5.0 |  | Systems Integration Testing (SIT) | Complete | COMPLETE |  |  |  |  |  |
| 1063 | 1.4.1.4.3.5.1.2 | Placing Reliance Stage 2 Review |  | 35d | 2024-04-15 A | 2024-05-31 A | 1062SS+9d | 100% |  | 2024-04-15 | 2024-05-31 | 35d |  |  |  |  |  | SI Test | PP | SIT | 5.12 |  | Systems Integration Testing (SIT) | Complete | COMPLETE |  |  |  |  |  |
| 1064 | 1.4.1.4.3.5.1.3 | Finalise Test Readiness Report and submit to Programme for assurance |  | 10d | 2024-04-30 A | 2024-05-13 A | 1062 | 100% |  | 2024-04-30 | 2024-05-13 | 10d | 2024-04-30 | 2024-05-13 |  |  |  | PP | SI Test | SIT | 5.0 |  | Systems Integration Testing (SIT) | Complete | COMPLETE |  |  |  |  |  |
| 1065 | 1.4.1.4.3.5.2 | **SI SIT Migration Test Readiness Report** |  | 40d | 2024-04-02 A | 2024-05-27 A |  | 100% |  | 2024-04-02 | 2024-05-27 | 40d | 2024-04-02 | 2024-05-27 |  |  |  | N/A | N/A | SIT | 5.0 | N/A | Systems Integration Testing (SIT) |  |  |  |  |  |  |  |
| 1066 | 1.4.1.4.3.5.2.1 | Assure Test Participants' Test Readiness Reports |  | 35d | 2024-04-02 A | 2024-05-20 A | 1062SS, 1064FF+5d | 100% |  | 2024-04-02 | 2024-05-20 | 35d | 2024-04-02 | 2024-05-20 |  |  |  | SI Test | PP,IPA | SIT | 5.0 |  | Systems Integration Testing (SIT) | Complete | COMPLETE |  |  |  |  |  |
| 1067 | 1.4.1.4.3.5.2.2 | Develop Overarching SIT Migration Test Readiness Report |  | 20d | 2024-04-23 A | 2024-05-20 A | 1066FF | 100% |  | 2024-04-23 | 2024-05-20 | 20d | 2024-04-23 | 2024-05-20 |  |  |  | SI Test |  | SIT | 5.0 |  | Systems Integration Testing (SIT) | Complete | COMPLETE |  |  |  |  |  |
| 1068 | 1.4.1.4.3.5.2.3 | Artefact review (via SITAG) and updates |  | 5d | 2024-05-21 A | 2024-05-27 A | 1067 | 100% |  | 2024-05-21 | 2024-05-27 | 5d | 2024-05-21 | 2024-05-27 |  |  |  | SI Test | PP,IPA | SIT | 5.0 |  | Systems Integration Testing (SIT) | Complete | COMPLETE |  |  |  |  |  |
| 1069 | 1.4.1.4.3.6 | SIT Migration Testing Preparation Complete | milestone | 0d | 2024-06-03 A | 2024-06-03 A | 1068FF+5d, 974, 372, 1063, 985, 991, 997 | 100% |  | 2024-06-03 | 2024-06-03 | 0d | 2024-06-03 | 2024-06-03 |  |  |  | SI Test | PP,IPA | SIT | 5.0 |  | Systems Integration Testing (SIT) | Complete | COMPLETE | T2-TE-0650 | SITAG | T2 |  |  |
| 1070 | 1.4.1.4.4 | **SIT Non-Functional Preparation** |  | 337d? | 2023-11-30 A | 2025-03-14 |  | 51% | 166.56d? | 2023-11-30 | 2025-03-14 | 193d | 2023-07-03 | 2024-08-26 | 724d |  | -0 | N/A | N/A | SIT | 5.0 | N/A | Systems Integration Testing (SIT) |  |  |  |  |  |  |  |
| 1071 | 1.4.1.4.4.1 | **Test Approach & Plan** |  | 120d | 2023-11-30 A | 2024-05-15 A |  | 100% |  | 2023-11-30 | 2024-05-15 | 120d | 2023-11-30 | 2024-03-20 |  |  | -0 | N/A | N/A | SIT | 5.0 | N/A | Systems Integration Testing (SIT) |  |  |  |  |  |  |  |
| 1072 | 1.4.1.4.4.1.1 | Develop document with SITWG |  | 67d | 2023-11-30 A | 2024-03-01 A |  | 100% |  | 2023-11-30 | 2024-03-01 | 67d | 2023-11-30 | 2024-01-10 |  | must start on 2023-11-30 |  | SI Test |  | SIT | 5.0 |  | Systems Integration Testing (SIT) | Complete | COMPLETE |  |  |  |  |  |
| 1073 | 1.4.1.4.4.1.2 | Draft document review with Code Bodies |  | 10d | 2024-03-04 A | 2024-03-15 A | 1072 | 100% |  | 2024-03-04 | 2024-03-15 | 10d | 2024-01-11 | 2024-01-24 |  |  |  | SI Test | Code Bodies | SIT | 5.0 |  | Systems Integration Testing (SIT) | Complete | COMPLETE |  |  |  |  |  |
| 1074 | 1.4.1.4.4.1.3 | Industry Consultation |  | 10d | 2024-03-18 A | 2024-03-29 A | 1073 | 100% |  | 2024-03-18 | 2024-03-29 | 10d |  |  |  |  |  | PP |  | SIT | 5.1 |  | Systems Integration Testing (SIT) | Complete | COMPLETE |  |  |  |  |  |
| 1075 | 1.4.1.4.4.1.4 | Industry Assurance Review |  | 5d | 2024-04-11 A | 2024-04-17 A | 1074FS+8d | 100% |  | 2024-04-11 | 2024-04-17 | 5d |  |  |  |  |  |  |  | SIT | 5.16 |  |  | Complete | COMPLETE |  |  |  |  |  |
| 1076 | 1.4.1.4.4.1.5 | SIT Non-Functional Testing Test Approach & Plan approved | milestone | 0d | 2024-05-15 A | 2024-05-15 A | 1075FS+20d | 100% |  | 2024-05-15 | 2024-05-15 | 0d | 2024-03-20 | 2024-03-20 |  |  |  | SI Test | PP | SIT | 5.30 | Roger Robar | Systems Integration Testing (SIT) | Complete | COMPLETE | T3-TE-0026 | SITAG | T3 | MHHS-ART073 | 30/7/24: Approved at esitag on 26/7/24 |

| ID | WBS | Task | Type | Duration | Start | Finish | Predecessors | Complete | Remaining | Actual finish | Baseline start | Baseline finish | Baseline duration | Baseline 1 start | Baseline 1 finish | Total slack | Free slack | Constraint | Baseline cost | Responsible | Involved | Text9 | Update Version | MHHS Resource Name | MHHS Programme Phase | Sched Status | RAG | Milestone ID | Text29 | Task Status | Guidance |
| --- | --- | --- | --- | --- | --- | --- | --- | --- | --- | --- | --- | --- | --- | --- | --- | --- | --- | --- | --- | --- | --- | --- | --- | --- | --- | --- | --- | --- | --- | --- | --- |
| 1077 | 1.4.1.4.4.2 | **Test Data Approach & Plan** |  | 41d | 2024-03-20 A | 2024-05-15 A |  | 100% |  |  | 2024-03-20 | 2024-05-15 | 41d | 2024-01-25 | 2024-03-20 |  |  |  | -0 | N/A | N/A | SIT | 5.0 | N/A | Systems Integration Testing (SIT) |  |  |  |  |  |  |
| 1078 | 1.4.1.4.4.2.1 | Industry Consultation |  | 14d | 2024-03-20 A | 2024-04-08 A | 1074SS+2d | 100% |  |  | 2024-03-20 | 2024-04-08 | 14d |  |  |  |  |  |  | PP |  | SIT | 5.1 | Richard Puddephatt | Systems Integration Testing (SIT) | Complete | COMPLETE |  |  |  |  |
| 1079 | 1.4.1.4.4.2.2 | Artefact review (via SITAG) and updates |  | 27d | 2024-04-09 A | 2024-05-15 A | 1078 | 100% |  |  | 2024-04-09 | 2024-05-15 | 27d | 2024-01-25 | 2024-03-13 |  |  |  |  | SI Test |  | SIT | 5.0 | Richard Puddephatt | Systems Integration Testing (SIT) | Complete | COMPLETE |  |  |  |  |
| 1080 | 1.4.1.4.4.2.3 | SIT Non-Functional Testing Test Data Approach & Plan approved | milestone | 0d | 2024-05-15 A | 2024-05-15 A | 1076FF, 1079 | 100% |  |  | 2024-05-15 | 2024-05-15 | 0d | 2024-03-20 | 2024-03-20 |  |  |  |  | SI Test | PP,IPA | SIT | 5.24 | Richard Puddephatt | Systems Integration Testing (SIT) | Complete | COMPLETE | T3-TE-0113 | SITAG |  |  |
| 1081 | 1.4.1.4.4.3 | **Test scenarios & Test Cases** |  | 98d? | 2024-03-04 A | 2024-07-17 |  | 76% | 23.87d? |  | 2024-03-04 | 2024-07-17 | 123d | 2023-07-24 | 2024-01-17 |  |  |  | -0 | N/A | N/A | SIT | 5.21 | N/A | Systems Integration Testing (SIT) |  |  |  |  |  |  |
| 1082 | 1.4.1.4.4.3.1 | **Theme 1** |  | 78d | 2024-03-04 A | 2024-06-19 A |  | 100% |  |  | 2024-03-04 | 2024-06-19 | 78d |  |  |  |  |  | -0 | N/A | N/A | SIT | 5.21 | N/A | Systems Integration Testing (SIT) |  |  |  |  | -448.67 |  |
| 1083 | 1.4.1.4.4.3.1.1 | Develop Test Scenarios & Test Cases |  | 33d | 2024-03-04 A | 2024-04-17 A | 1072 | 100% |  |  | 2024-03-04 | 2024-04-17 | 33d |  |  |  |  |  |  | SI Test | SI Test, PP | SIT | 5.21 |  |  | Complete | COMPLETE |  |  |  |  |
| 1084 | 1.4.1.4.4.3.1.2 | Industry Review Workshop |  | 1d | 2024-04-18 A | 2024-04-18 A | 1083 | 100% |  |  | 2024-04-18 | 2024-04-18 | 1d |  |  |  |  |  |  | SI Test, PP | SI Test, PP | SIT | 5.21 |  |  | Complete | COMPLETE |  |  |  |  |
| 1085 | 1.4.1.4.4.3.1.3 | Industry Consultation Review |  | 7d | 2024-05-02 A | 2024-05-10 A | 1084FS+9d | 100% |  |  | 2024-05-02 | 2024-05-10 | 7d |  |  |  |  |  |  | SI Test, PP | SI Test, PP | SIT | 5.21 |  |  | Complete | COMPLETE |  |  |  |  |
| 1086 | 1.4.1.4.4.3.1.4 | Review with NFT Working Group |  | 5d | 2024-05-31 A | 2024-06-06 A | 1085FS+14d | 100% |  |  | 2024-05-31 | 2024-06-06 | 5d |  |  |  |  |  |  | SI Test, PP | SI Test, PP | SIT | 5.21 |  |  | Complete | COMPLETE |  |  |  |  |
| 1087 | 1.4.1.4.4.3.1.5 | SIT NFT Scenarios & Test Cases Approved - Theme 1 | milestone | 0d | 2024-06-19 A | 2024-06-19 A | 1086FS+9d | 100% |  |  | 2024-06-19 | 2024-06-19 | 0d |  |  |  |  |  |  | SI Test | SI Test, PP | SIT | 5.30 | Roger Robar | Systems Integration Testing (SIT) | Complete | COMPLETE | T3-TE-0114 | SITAG |  | 30/7/24: Approved at esitag on 26/7/24 |
| 1088 | 1.4.1.4.4.3.2 | **Theme 2** |  | 98d | 2024-03-04 A | 2024-07-17 A |  | 100% |  |  | 2024-03-04 | 2024-07-17 | 98d |  |  |  |  |  |  | N/A | N/A | SIT | 5.21 | N/A | Systems Integration Testing (SIT) |  |  |  |  | -448.67 |  |
| 1089 | 1.4.1.4.4.3.2.1 | Develop Test Scenarios & Test Cases |  | 53d | 2024-03-04 A | 2024-05-15 A | 1072 | 100% |  |  | 2024-03-04 | 2024-05-15 | 53d |  |  |  |  |  |  | SI Test | SI Test, PP | SIT | 5.21 |  |  | Complete | COMPLETE |  |  |  |  |
| 1090 | 1.4.1.4.4.3.2.2 | Industry Review Workshop |  | 1d | 2024-05-16 A | 2024-05-16 A | 1089 | 100% |  |  | 2024-05-16 | 2024-05-16 | 1d |  |  |  |  |  |  | SI Test, PP | SI Test, PP | SIT | 5.21 |  |  | Complete | COMPLETE |  |  |  |  |
| 1091 | 1.4.1.4.4.3.2.3 | Industry Consultation Review |  | 7d | 2024-05-20 A | 2024-05-28 A | 1090FS+1d | 100% |  |  | 2024-05-20 | 2024-05-28 | 7d |  |  |  |  |  |  | SI Test, PP | SI Test, PP | SIT | 5.21 |  |  | Complete | COMPLETE |  |  |  |  |
| 1092 | 1.4.1.4.4.3.2.4 | Review with NFT Working Group |  | 5d | 2024-06-28 A | 2024-07-04 A | 1091FS+22d | 100% |  |  | 2024-06-28 | 2024-07-04 | 5d |  |  |  |  |  |  | SI Test, PP | SI Test, PP | SIT | 5.21 |  |  | Complete | COMPLETE |  |  |  |  |
| 1093 | 1.4.1.4.4.3.2.5 | SIT NFT Scenarios & Test Cases Approved - Theme 2 | milestone | 0d | 2024-07-17 A | 2024-07-17 A | 1092FS+9d | 100% |  |  | 2024-07-17 | 2024-07-17 | 0d |  |  |  |  |  |  | SI Test | SI Test, PP | SIT | 5.22 |  | Systems Integration Testing (SIT) | Complete | COMPLETE | T3-TE-0115 | SITAG |  |  |
| 1094 | 1.4.1.4.4.3.3 | **Theme 3** |  | 98d? | 2024-03-04 A | 2024-07-17 |  | 100% |  | 2024-09-18 | 2024-03-04 | 2024-07-17 | 123d |  |  |  |  |  | -0 | N/A | N/A | SIT | 6.0 | N/A | Systems Integration Testing (SIT) |  |  |  |  | -448.67 |  |
| 1095 | 1.4.1.4.4.3.3.1 | Develop Test Scenarios & Test Cases |  | 63d | 2024-03-04 A | 2024-05-29 A | 1072 | 100% |  |  | 2024-03-04 | 2024-05-29 | 63d |  |  |  |  |  |  | SI Test | SI Test, PP | SIT | 6.0 |  |  | Complete | COMPLETE |  |  |  |  |
| 1096 | 1.4.1.4.4.3.3.2 | Industry Review Workshop |  | 1d | 2024-05-30 A | 2024-05-30 A | 1095 | 100% |  |  | 2024-05-30 | 2024-05-30 | 1d |  |  |  |  |  |  | SI Test, PP | SI Test, PP | SIT | 6.0 |  |  | Complete | COMPLETE |  |  |  |  |
| 1097 | 1.4.1.4.4.3.3.3 | Industry Consultation Review |  | 6d | 2024-06-10 A | 2024-06-17 A | 1096FS+6d | 100% |  |  | 2024-06-10 | 2024-06-17 | 6d |  |  |  |  |  |  | SI Test, PP | SI Test, PP | SIT | 6.0 |  |  | Complete | COMPLETE |  |  |  |  |
| 1098 | 1.4.1.4.4.3.3.4 | Review with NFT Working Group |  | 5d | 2024-06-28 A | 2024-07-04 A | 1097FS+8d | 100% |  |  | 2024-06-28 | 2024-07-04 | 30d |  |  |  |  |  |  | SI Test, PP | SI Test, PP | SIT | 6.0 | Roger Robar |  | Complete | COMPLETE |  |  |  |  |
| 1099 | 1.4.1.4.4.3.3.5 | SIT NFT Scenarios & Test Cases Approved - Theme 3 | milestone | 0d | 2024-09-18 A | 2024-09-18 A | 1098FS+9d | 100% |  |  | 2024-09-18 | 2024-09-18 | 0d |  |  |  |  | start no earlier than 2024-09-18 |  | SI Test | SI Test, PP | SIT | 5.30 | Roger Robar | Systems Integration Testing (SIT) | Complete | COMPLETE | T3-TE-0116 | SITAG |  | 31/7/24: baseline date change approved at esitag on 26/7/24 |
| 1100 | 1.4.1.4.4.3.4 | **SIT NFT Programme RTTM** |  | 56d? | 2024-09-18 A | 2024-12-04 |  | 27% | 41d? |  | 2024-09-18 | 2024-10-16 | 0d |  |  | 796d |  |  |  |  |  | SIT | 6.11 |  |  | Overdue Start |  |  |  | -197.67 |  |
| 1101 | 1.4.1.4.4.3.4.1 | Develop Manual SIT NFT RTTM |  | 30d | 2024-09-18 A | 2024-10-29 | 1099 | 50% | 15d |  | 2024-09-18 | 2024-10-29 | 0d |  |  | 796d | 0d |  |  |  |  | SIT | 6.11 |  |  | Green | GREEN |  |  |  |  |
| 1102 | 1.4.1.4.4.3.4.2 | LDP peer review |  | 10d | 2024-10-30 | 2024-11-12 | 1101 |  |  |  | 2024-10-30 | 2024-11-12 | 0d |  |  | 796d | 0d |  |  |  |  | SIT | 6.11 |  |  | Green | GREEN |  |  | -0.67 |  |
| 1103 | 1.4.1.4.4.3.4.3 | Review with SRO |  | 5d | 2024-11-13 | 2024-11-19 | 1102 |  |  |  | 2024-11-13 | 2024-11-19 | 0d |  |  | 796d | 0d |  |  |  |  | SIT | 6.11 |  |  | Green | GREEN |  |  | 13.33 |  |
| 1104 | 1.4.1.4.4.3.4.4 | Manual SIT NFT RTTM Complete | milestone | 0d | 2024-11-19 | 2024-11-19 | 1103 |  |  |  | 2024-11-19 | 2024-11-19 | 0d |  |  | 796d | 0d |  |  |  |  | SIT | 6.11 |  |  | Green | GREEN |  |  | 19.71 |  |
| 1105 | 1.4.1.4.4.3.4.5 | Develop Automated SIT NFT RTTM |  | 10d | 2024-11-20 | 2024-12-03 | 1104 |  |  |  | 2024-11-20 | 2024-12-03 | 0d |  |  | 796d | 0d |  |  |  |  | SIT | 6.11 |  |  | Green | GREEN |  |  | 20.33 |  |
| 1106 | 1.4.1.4.4.3.4.6 | Review with SRO |  | 1d? | 2024-12-04 | 2024-12-04 | 1105 |  |  |  | 2024-12-04 | 2024-12-04 | 0d |  |  | 796d |  |  |  |  |  | SIT | 6.11 |  |  | Green | GREEN |  |  | 34.33 |  |
| 1107 | 1.4.1.4.4.3.4.7 | Automated SIT NFT RTTM Complete | milestone | 0d | 2024-12-03 | 2024-12-03 | 1105 |  |  |  | 2024-12-03 | 2024-12-03 | 0d |  |  | 797d |  |  |  |  |  | SIT | 6.11 |  |  | Green | GREEN |  |  | 33.71 |  |

| ID | WBS | Task | Type | Duration | Start | Finish | Predecessors | Complete | Remaining | Baseline start | Baseline finish | Baseline duration | Baseline 1 start | Baseline 1 finish | Total slack | Free slack | Constraint | Baseline cost | Text9 | Task Status | Update Version | Sched Status | RAG | Responsible | Involved | MHHS Resource Name | MHHS Programme Phase | Action |
| --- | --- | --- | --- | --- | --- | --- | --- | --- | --- | --- | --- | --- | --- | --- | --- | --- | --- | --- | --- | --- | --- | --- | --- | --- | --- | --- | --- | --- |
| 1108 | 1.4.1.4.4.3.5 | **NFT Performance Tool Theme 1 Setup** |  | 225d? | 2024-03-04 A | 2025-01-10 |  | 68% | 73d? | 2024-03-04 | 2025-01-10 | 0d |  |  | 769d |  |  |  | SIT | -205.67 | 6.1 | Overdue Start | RED |  |  |  |  |  |
| 1109 | 1.4.1.4.4.3.5.1 | Theme 1 injection tool initial POC |  | 85d? | 2024-03-04 A | 2024-06-28 A |  | 100% |  | 2024-03-04 | 2024-06-28 | 0d |  |  |  |  |  |  | SIT |  | 6.1 | Complete | COMPLETE |  |  |  |  |  |
| 1110 | 1.4.1.4.4.3.5.2 | Theme 1 injection tool configuration and validation against DIP SIM (IR7.1) |  | 38d | 2024-07-01 A | 2024-08-21 A | 1109 | 100% |  | 2024-07-01 | 2024-08-21 | 0d |  |  |  |  |  |  | SIT |  | 6.1 | Complete | COMPLETE |  |  |  |  |  |
| 1111 | 1.4.1.4.4.3.5.3 | Theme 1 injection tool configuration and validation against DIP SIM (IR8.1) |  | 29d | 2024-08-22 A | 2024-10-01 A | 1110 | 100% |  | 2024-08-22 | 2024-10-01 | 0d |  |  |  |  |  |  | SIT |  | 6.1 | Complete | COMPLETE |  |  |  |  |  |
| 1112 | 1.4.1.4.4.3.5.4 | Theme 1 injection tool configuration and validation againast UIT DIP (IR8.1) |  | 11d | 2024-10-02 | 2024-10-16 | 1111 |  |  | 2024-10-02 | 2024-10-16 | 0d |  |  | 769d | 0d |  |  | SIT | -28.67 | 6.1 | Overdue Start | RED |  |  |  |  |  |
| 1113 | 1.4.1.4.4.3.5.5 | Theme 1 injection tool configuration and validation against SIT-B DIP (IR8.3) |  | 62d? | 2024-10-17 | 2025-01-10 | 1112 |  |  | 2024-10-17 | 2025-01-10 | 0d |  |  | 769d |  |  |  | SIT | -13.67 | 6.1 | Overdue Start | GREEN |  |  |  |  |  |
| 1114 | 1.4.1.4.4.4 | **Environments (SIT B)** |  | 94d? | 2024-08-27 A | 2025-01-03 |  |  | 94d? | 2024-08-27 | 2025-01-03 | 0d | 2024-07-30 | 2024-08-05 | 60d |  |  | -0 | SIT |  | 5.0 |  |  | N/A | N/A | N/A | Systems Integration Testing (SIT) |  |
| 1115 | 1.4.1.4.4.4.1 | **PP Environments (SIT B)** |  | 0d | 2024-08-27 A | 2024-08-27 A |  | 100% |  | 2024-08-27 | 2024-08-27 | 0d | 2024-07-30 | 2024-08-05 |  |  |  | -0 | SIT |  | 5.0 |  |  | N/A | N/A | N/A | Systems Integration Testing (SIT) |  |
| 1116 | 1.4.1.4.4.4.1.1 | Deployment of MHHS solution code to SIT B environments | milestone | 0d | 2024-08-27 A | 2024-08-27 A |  | 100% |  | 2024-08-27 | 2024-08-27 | 0d | 2024-07-30 | 2024-08-05 |  |  | start no earlier than 2024-08-27 |  | SIT |  | 5.21 | Complete | COMPLETE | PP | SI Test | Heath Thomas | Systems Integration Testing (SIT) | 26/3/24: Lee said change to SB and align to IR7 |
| 1117 | 1.4.1.4.4.4.2 | **SI Environments (SIT B)** |  | 0d | 2024-08-27 A | 2024-08-27 A |  | 100% |  | 2024-08-27 | 2024-08-27 | 0d | 2024-07-30 | 2024-08-05 |  |  |  | -0 | SIT |  | 5.0 |  |  | N/A | N/A | N/A | Systems Integration Testing (SIT) |  |
| 1118 | 1.4.1.4.4.4.2.1 | Coordinate deployment of MHHS solution code to SIT Participants' SIT B environments | milestone | 0d | 2024-08-27 A | 2024-08-27 A | 1116SS | 100% |  | 2024-08-27 | 2024-08-27 | 0d | 2024-07-30 | 2024-08-05 |  |  |  |  | SIT |  | 5.21 | Complete | COMPLETE | SI Test | PP | Heath Thomas | Systems Integration Testing (SIT) |  |
| 1119 | 1.4.1.4.4.4.3 | **Helix and Avanade Environments Upscale** |  | 10d? | 2024-12-23 | 2025-01-03 |  |  |  | 2024-12-23 | 2025-01-03 | 0d |  |  | 60d |  |  |  | SIT | -686.67 | 6.0 | Overdue Start |  |  |  |  |  |  |
| 1120 | 1.4.1.4.4.4.3.1 | Environment Uplift Window |  | 10d? | 2024-12-23 | 2025-01-03 | 1366 |  |  | 2024-12-23 | 2025-01-03 | 0d |  |  | 60d | 0d |  |  | SIT | 53.33 | 6.0 | Green | GREEN |  |  |  |  |  |
| 1121 | 1.4.1.4.4.5 | **Test Data - Non-Functional and Operational (SIT B)** |  | 50d? | 2025-01-06 | 2025-03-14 |  |  |  | 2025-01-06 | 2025-03-14 | 0d |  |  | 60d |  |  |  | SIT | -686.67 | 6.0 | Overdue Start |  |  |  |  |  |  |
| 1122 | 1.4.1.4.4.5.1 | **Data Load** |  | 50d? | 2025-01-06 | 2025-03-14 |  |  |  | 2025-01-06 | 2025-03-14 | 0d |  |  | 60d |  |  |  | SIT | -689.67 | 6.0 | Overdue Start |  |  |  | Richard Puddephatt |  |  |
| 1123 | 1.4.1.4.4.5.1.1 | Non-Functional Theme 1 (Helix & DIP Volume Testing) Data Load |  | 5d? | 2025-01-06 | 2025-01-10 | 1120 |  |  | 2025-01-06 | 2025-01-10 | 0d |  |  | 60d | 0d |  |  | SIT | 67.33 | 6.0 | Green | GREEN |  |  | Richard Puddephatt |  |  |
| 1124 | 1.4.1.4.4.5.1.2 | Non-Functional Theme 2 & 3 (Helix and DIP) Data Load |  | 5d | 2025-02-03 | 2025-02-07 | 1422 |  |  | 2025-02-03 | 2025-02-07 | 0d |  |  | 70d | 0d |  |  | SIT | 95.33 | 6.0 | Green | GREEN |  |  | Richard Puddephatt |  |  |
| 1125 | 1.4.1.4.4.5.1.3 | Non-Functional Themes 2 & 3 (Central Parties and PPs) Data Load |  | 20d? | 2025-01-06 | 2025-01-31 | 1120 |  |  | 2025-01-06 | 2025-01-31 | 0d |  |  | 100d | 30d |  |  | SIT | 67.33 | 6.0 | Green | GREEN |  |  | Richard Puddephatt |  |  |
| 1126 | 1.4.1.4.4.5.1.4 | Operational Themes 1, 2 & 3 (Batch 2) (Central Parties and PPs) Data Load |  | 20d? | 2025-01-06 | 2025-01-31 | 1120 |  |  | 2025-01-06 | 2025-01-31 | 0d |  |  | 65d | 5d | start no earlier than 2025-01-06 |  | SIT | 67.33 | 6.0 | Green | GREEN |  |  | Richard Puddephatt |  |  |
| 1127 | 1.4.1.4.4.5.1.5 | Operational Themes 1, 2 & 3 (Batch 2) (Helix & DIP) Data Load |  | 5d | 2025-02-03 | 2025-02-07 | 1422 |  |  | 2025-02-03 | 2025-02-07 | 0d |  |  | 60d | 0d |  |  | SIT | 95.33 | 6.0 | Green | GREEN |  |  | Richard Puddephatt |  |  |
| 1128 | 1.4.1.4.4.5.1.6 | Non-Functional and Operational Test Data Preparation Complete | milestone | 0d | 2025-02-07 | 2025-02-07 | 1127 |  |  | 2025-02-07 | 2025-02-07 | 0d |  |  | 749d |  |  |  | SIT | 99.71 | 6.0 | Green | GREEN |  |  | Richard Puddephatt |  |  |
| 1129 | 1.4.1.4.4.5.1.7 | Non-Functional Theme 2 & 3 PP Preparation |  | 25d? | 2025-02-10 | 2025-03-14 | 1124 |  |  | 2025-02-10 | 2025-03-14 | 0d |  |  | 70d | 0d |  |  | SIT | 102.33 | 6.0 | Green | GREEN |  |  | Richard Puddephatt |  |  |
| 1130 | 1.4.1.4.4.6 | **SIT Non-Functional Test Readiness Report** |  | 184d | 2024-06-25 A | 2025-03-07 |  | 19% | 148.71d | 2024-06-25 | 2025-03-07 | 44d | 2024-06-25 | 2024-08-19 | 70d |  |  | -0 | SIT |  | 5.0 |  |  | N/A | N/A | N/A | Systems Integration Testing (SIT) |  |
| 1131 | 1.4.1.4.4.6.1 | **PP SIT Non-Functional Test Readiness Report** |  | 184d | 2024-06-25 A | 2025-03-07 |  | 18% | 150.71d | 2024-06-25 | 2025-03-07 | 44d | 2024-06-25 | 2024-08-05 | 70d |  |  | -0 | SIT |  | 5.0 |  |  | N/A | N/A | N/A | Systems Integration Testing (SIT) |  |
| 1132 | 1.4.1.4.4.6.1.1 | Develop draft Test Readiness Report and submit to Programme for assurance |  | 20d | 2024-06-25 A | 2024-07-22 A |  | 100% |  | 2024-06-25 | 2024-07-22 | 20d | 2024-06-25 | 2024-07-22 |  |  | start no earlier than 2024-06-25 |  | SIT |  | 5.0 | Complete | COMPLETE | PP | SI Test | Roger Robar | Systems Integration Testing (SIT) |  |
| 1133 | 1.4.1.4.4.6.1.2 | Placing Reliance Stage 2 Review |  | 180d | 2024-07-01 A | 2025-03-07 |  | 16% | 152d | 2024-07-01 | 2025-03-07 | 40d |  |  | 70d | 0d |  |  | SIT |  | 5.12 | Green | GREEN | SI Test | PP | Roger Robar | Systems Integration Testing (SIT) |  |
| 1134 | 1.4.1.4.4.6.1.3 | Finalise Test Readiness Report and submit to Programme for assurance |  | 104d | 2024-07-23 A | 2024-12-13 | 1132 | 7% | 97d | 2024-07-23 | 2024-12-13 | 10d | 2024-07-23 | 2024-08-05 | 7d | 0d |  |  | SIT |  | 5.0 | Green | GREEN | PP | SI Test | Roger Robar | Systems Integration Testing (SIT) |  |

Notes:
- 1118: 25/3: SB - Date aligns to IR8 code delivery for SIT B
- 1133: 04/10/24 - Duration has been reduced so it finis
- 1134: 10/10/24 - Duration extended to 94 days.

| ID | WBS | Task | Type | Duration | Start | Finish | Predecessors | Complete | Remaining | Baseline start | Baseline finish | Baseline duration | Baseline 1 start | Baseline 1 finish | Total slack | Free slack | Constraint | Baseline cost | Responsible | Involved | Text9 | Update Version | MHHS Resource Name | MHHS Programme Phase | Sched Status | RAG | Task Status | Milestone ID | Text29 | Tier | Artefact ID | Guidance |
| --- | --- | --- | --- | --- | --- | --- | --- | --- | --- | --- | --- | --- | --- | --- | --- | --- | --- | --- | --- | --- | --- | --- | --- | --- | --- | --- | --- | --- | --- | --- | --- | --- |
| 1135 | 1.4.1.4.4.6.2 | **SI SIT Non-Functional Test Readiness Report** |  | 144d | 2024-06-25 A | 2025-01-10 |  | 22% | 112.84d | 2024-06-25 | 2025-01-10 | 40d | 2024-06-25 | 2024-08-19 | 95d |  |  |  | N/A | N/A | SIT | 5.0 | N/A | Systems Integration Testing (SIT) |  |  |  |  |  |  |  |  |
| 1136 | 1.4.1.4.4.6.2.1 | Assure Test Participants' Test Readiness Reports |  | 114d | 2024-06-25 A | 2024-12-13 | 1132SS, 1134FF | 19% | 92d | 2024-06-25 | 2024-12-13 | 35d | 2024-06-25 | 2024-08-12 | 7d | 0d |  |  | SI Test | PP,IPA | SIT | 5.0 | Roger Robar | Systems Integration Testing (SIT) | Green | GREEN |  |  |  |  |  |  |
| 1137 | 1.4.1.4.4.6.2.2 | Develop Overarching SIT Non-Functional Test Readiness Report |  | 15d | 2024-12-02 A | 2024-12-20 | 1136FS-10d | 47% | 8d | 2024-12-02 | 2024-12-20 | 20d | 2024-07-16 | 2024-08-12 | 95d | 0d |  |  | SI Test |  | SIT | 5.0 | Roger Robar | Systems Integration Testing (SIT) | Green | GREEN |  |  |  |  |  |  |
| 1138 | 1.4.1.4.4.6.2.3 | Artefact review (via SITAG / SRO) and updates |  | 5d | 2025-01-06 | 2025-01-10 | 1137FS+10d |  |  | 2025-01-06 | 2025-01-10 | 5d | 2024-08-13 | 2024-08-19 | 95d | 25d |  |  | SI Test | PP,IPA | SIT | 5.0 | Roger Robar | Systems Integration Testing (SIT) | Green | GREEN | 67.33 |  |  |  |  |  |
| 1139 | 1.4.1.4.4.7 | SIT Non-Functional Testing Preparation Complete | milestone | 0d | 2025-03-07 | 2025-03-07 | 1138FF+15d, 833, 389, 1087, 1093, 1099, 1133 |  |  | 2025-03-07 | 2025-03-07 | 0d | 2024-08-26 | 2024-08-26 | 70d | 0d |  |  | SI Test | PP,IPA | SIT | 5.0 | Roger Robar | Systems Integration Testing (SIT) | Green | AMBER | 127.71 | T2-TE-0700 | SITAG | T2 |  |  |
| 1140 | 1.4.1.4.5 | **SIT Operational Preparation** |  | 263d? | 2024-02-01 A | 2025-02-03 |  | 35% | 171.99d? | 2024-02-01 | 2025-01-31 | 283d | 2023-08-03 | 2025-03-10 | 753d |  |  | -0 | N/A | N/A | SIT | 5.0 | N/A | Systems Integration Testing (SIT) |  |  |  |  |  |  |  |  |
| 1141 | 1.4.1.4.5.1 | **Test Approach & Plan** |  | 75d | 2024-02-01 A | 2024-05-15 A |  | 100% |  | 2024-02-01 | 2024-05-15 | 75d | 2024-02-01 | 2024-05-15 |  |  |  | -0 | N/A | N/A | SIT | 5.0 | N/A | Systems Integration Testing (SIT) |  |  |  |  |  |  |  |  |
| 1142 | 1.4.1.4.5.1.1 | Develop document with SITWG |  | 25d | 2024-02-01 A | 2024-03-06 A |  | 100% |  | 2024-02-01 | 2024-03-06 | 25d | 2024-02-01 | 2024-03-06 |  |  | must start on 2024-02-01 |  | SI Test |  | SIT | 5.0 |  | Systems Integration Testing (SIT) | Complete | COMPLETE |  |  |  |  |  |  |
| 1143 | 1.4.1.4.5.1.2 | Draft document review with Code Bodies |  | 4d | 2024-03-21 A | 2024-03-26 A | 1142FS+10d | 100% |  | 2024-03-21 | 2024-03-26 | 10d | 2024-03-07 | 2024-03-20 |  |  |  |  | SI Test | Code Bodies | SIT | 5.0 |  | Systems Integration Testing (SIT) | Complete | COMPLETE |  |  |  |  |  |  |
| 1144 | 1.4.1.4.5.1.3 | Industry Consultation |  | 10d | 2024-03-27 A | 2024-04-09 A | 1143 | 100% |  | 2024-03-27 | 2024-04-09 | 10d |  |  |  |  |  |  | PP |  | SIT | 5.1 |  | Systems Integration Testing (SIT) | Complete | COMPLETE |  |  |  |  |  |  |
| 1145 | 1.4.1.4.5.1.4 | Artefact review (via SITAG) and updates |  | 26d | 2024-04-10 A | 2024-05-15 A | 1144 | 100% |  | 2024-04-10 | 2024-05-15 | 30d | 2024-03-21 | 2024-05-15 |  |  |  |  | SI Test | PP,IPA,Code Bodies | SIT | 5.0 |  | Systems Integration Testing (SIT) | Complete | COMPLETE |  |  |  |  |  |  |
| 1146 | 1.4.1.4.5.1.5 | SIT Operational Testing Test Approach & Plan approved | milestone | 0d | 2024-05-15 A | 2024-05-15 A | 1145 | 100% |  | 2024-05-15 | 2024-05-15 | 0d | 2024-05-15 | 2024-05-15 |  |  |  |  | SI Test | PP | SIT | 5.24 |  | Systems Integration Testing (SIT) | Complete | COMPLETE |  | T3-TE-0029 | SITAG | T3 | MHHS-ART073 |  |
| 1147 | 1.4.1.4.5.2 | **Test Data Approach & Plan** |  | 36d | 2024-03-27 A | 2024-05-15 A |  | 100% |  | 2024-03-27 | 2024-05-15 | 36d | 2024-03-21 | 2024-05-15 |  |  |  | -0 | N/A | N/A | SIT | 5.0 | N/A | Systems Integration Testing (SIT) |  |  |  |  |  |  |  |  |
| 1148 | 1.4.1.4.5.2.1 | Industry Consultation |  | 10d | 2024-03-27 A | 2024-04-09 A | 1144SS | 100% |  | 2024-03-27 | 2024-04-09 | 10d |  |  |  |  |  |  | PP |  | SIT | 5.1 | Richard Puddephatt | Systems Integration Testing (SIT) | Complete | COMPLETE |  |  |  |  |  |  |
| 1149 | 1.4.1.4.5.2.2 | Artefact review (via SITAG) and updates |  | 26d | 2024-04-10 A | 2024-05-15 A | 1148 | 100% |  | 2024-04-10 | 2024-05-15 | 26d | 2024-03-21 | 2024-05-15 |  |  |  |  | SI Test |  | SIT | 5.0 | Richard Puddephatt | Systems Integration Testing (SIT) | Complete | COMPLETE |  |  |  |  |  |  |
| 1150 | 1.4.1.4.5.2.3 | SIT Operational Testing Test Data Approach & Plan approved | milestone | 0d | 2024-05-15 A | 2024-05-15 A | 1149 | 100% |  | 2024-05-15 | 2024-05-15 | 0d | 2024-05-15 | 2024-05-15 |  |  |  |  | SI Test | PP,IPA | SIT | 5.0 | Richard Puddephatt | Systems Integration Testing (SIT) | Complete | COMPLETE |  |  |  |  |  |  |
| 1151 | 1.4.1.4.5.3 | **Test scenarios & Test Cases** |  | 214d? | 2024-04-10 A | 2025-02-03 |  | 28% | 153.51d? | 2024-04-10 | 2025-01-31 | 116d | 2023-07-24 | 2024-01-17 | 753d |  |  | -0 | N/A | N/A | SIT | 5.21 | N/A | Systems Integration Testing (SIT) |  |  |  |  |  |  |  |  |
| 1152 | 1.4.1.4.5.3.1 | **Theme 1** |  | 108d | 2024-04-10 A | 2024-09-06 A |  | 100% |  | 2024-04-10 | 2024-09-06 | 96d |  |  |  |  |  | -0 | N/A | N/A | SIT | 6.0 | N/A | Systems Integration Testing (SIT) |  |  | -448.67 |  |  |  |  |  |
| 1153 | 1.4.1.4.5.3.1.1 | Develop Test Scenarios & Test Cases |  | 53d | 2024-04-10 A | 2024-06-21 A | 1144 | 100% |  | 2024-04-10 | 2024-06-21 | 16d |  |  |  |  |  |  | SI Test | SI Test, PP | SIT | 6.0 |  |  | Complete | COMPLETE |  |  |  |  |  |  |
| 1154 | 1.4.1.4.5.3.1.2 | Industry Review Workshop |  | 1d | 2024-06-24 A | 2024-06-24 A | 1153 | 100% |  | 2024-06-24 | 2024-06-24 | 1d |  |  |  |  |  |  | SI Test, PP | SI Test, PP | SIT | 6.0 |  |  | Complete | COMPLETE |  |  |  |  |  |  |
| 1155 | 1.4.1.4.5.3.1.3 | Industry Consultation Review |  | 6d | 2024-07-02 A | 2024-07-09 A | 1154FS+17d | 100% |  | 2024-07-02 | 2024-07-09 | 6d |  |  |  |  |  |  | SI Test, PP | SI Test, PP | SIT | 6.0 |  |  | Complete | COMPLETE |  |  |  |  |  |  |
| 1156 | 1.4.1.4.5.3.1.4 | Review with SIT Working Group |  | 5d | 2024-08-19 A | 2024-08-23 A | 1155FS+16d | 100% |  | 2024-08-19 | 2024-08-23 | 5d |  |  |  |  |  |  | SI Test, PP | SI Test, PP | SIT | 6.0 |  |  | Complete | COMPLETE |  |  |  |  |  |  |
| 1157 | 1.4.1.4.5.3.1.5 | SIT Operational Scenarios & Test Cases Approved - Theme 1 | milestone | 0d | 2024-09-06 A | 2024-09-06 A | 1156FS+10d | 100% |  | 2024-09-06 | 2024-09-06 | 0d |  |  |  |  | start no earlier than 2024-09-06 |  | SI Test | SI Test, PP | SIT | 6.0 | Roger Robar | Systems Integration Testing (SIT) | Complete | COMPLETE |  | T3-TE-0117 | SITAG |  |  | 31/7/24: baseline date change approved at esitag on 26/7/24 |
| 1158 | 1.4.1.4.5.3.2 | **Theme 2** |  | 107d | 2024-04-10 A | 2024-09-06 A |  | 100% |  | 2024-04-10 | 2024-09-06 | 71d |  |  |  |  |  |  | N/A | N/A | SIT | 6.0 | N/A | Systems Integration Testing (SIT) |  |  | -448.67 |  |  |  |  |  |
| 1159 | 1.4.1.4.5.3.2.1 | Develop Test Scenarios & Test Cases |  | 53d | 2024-04-10 A | 2024-06-21 A | 1144 | 100% |  | 2024-04-10 | 2024-06-21 | 31d |  |  |  |  | finish no earlier than 2024-06-21 |  | SI Test | SI Test, PP | SIT | 6.0 |  |  | Complete | COMPLETE |  |  |  |  |  |  |
| 1160 | 1.4.1.4.5.3.2.2 | Industry Review Workshop |  | 1d | 2024-06-24 A | 2024-06-24 A | 1159 | 100% |  | 2024-06-24 | 2024-06-24 | 1d |  |  |  |  |  |  | SI Test, PP | SI Test, PP | SIT | 6.0 |  |  | Complete | COMPLETE |  |  |  |  |  |  |
| 1161 | 1.4.1.4.5.3.2.3 | Industry Consultation Review |  | 6d | 2024-07-02 A | 2024-07-09 A | 1160FS+7d | 100% |  | 2024-07-02 | 2024-07-09 | 6d |  |  |  |  |  |  | SI Test, PP | SI Test, PP | SIT | 6.0 |  |  | Complete | COMPLETE |  |  |  |  |  |  |
| 1162 | 1.4.1.4.5.3.2.4 | Review with SIT Working Group |  | 5d | 2024-08-19 A | 2024-08-23 A | 1161FS+11d | 100% |  | 2024-08-19 | 2024-08-23 | 5d |  |  |  |  |  |  | SI Test, PP | SI Test, PP | SIT | 6.0 |  |  | Complete | COMPLETE |  |  |  |  |  |  |
| 1163 | 1.4.1.4.5.3.2.5 | SIT Operational Scenarios & Test Cases Approved - Theme 2 | milestone | 0d | 2024-09-06 A | 2024-09-06 A | 1162FS+10d | 100% |  | 2024-09-06 | 2024-09-06 | 0d |  |  |  |  |  |  | SI Test | SI Test, PP | SIT | 6.0 |  | Systems Integration Testing (SIT) | Complete | COMPLETE |  | T3-TE-0118 | SITAG |  |  |  |

Notes:
- 1139: Date missed due to lower than expected SIT functional test velocity. Forecast date updated and will be baselined once CR55 is approved.

| ID | WBS | Task | Duration | Start | Finish | Baseline start | Baseline finish | Baseline duration | Total slack | Free slack | Constraint | Text9 | Task Status | Update Version | Sched Status | RAG |
| --- | --- | --- | --- | --- | --- | --- | --- | --- | --- | --- | --- | --- | --- | --- | --- | --- |
| 1164 | 1.4.1.4.5.3.3 | **Elexon / Helix Service Management Test Prep** | 146d? | 2024-07-15 | 2025-02-03 | 2024-07-15 | 2025-01-31 | 0d | 15d |  |  | SIT | -688.67 | 6.0 | Overdue Start |  |
| 1165 | 1.4.1.4.5.3.3.1 | Elexon Service Now Build and Implementation | 145d? | 2024-07-15 | 2025-01-31 | 2024-07-15 | 2025-01-31 | 0d | 115d | 0d | start no earlier than 2024-07-15 | SIT | -107.67 | 6.0 | Overdue Start | GREEN |
| 1166 | 1.4.1.4.5.3.3.2 | **Incident Management Build** | 75d? | 2024-08-05 | 2024-11-15 | 2024-08-05 | 2024-11-15 | 0d |  |  |  | SIT | -728.67 | 6.11 | Overdue Start |  |
| 1167 | 1.4.1.4.5.3.3.2.1 | Build | 1d? | 2024-09-27 | 2024-09-27 | 2024-09-27 | 2024-09-27 | 0d | 844d |  | finish no earlier than 2024-09-27 | SIT | -33.67 | 6.11 | Overdue Start | RED |
| 1168 | 1.4.1.4.5.3.3.2.2 | Test | 1d? | 2024-10-18 | 2024-10-18 | 2024-10-18 | 2024-10-18 | 0d | 829d |  | finish no earlier than 2024-10-18 | SIT | -12.67 | 6.11 | Overdue Start | RED |
| 1169 | 1.4.1.4.5.3.3.2.3 | Deploy | 1d? | 2024-11-15 | 2024-11-15 | 2024-11-15 | 2024-11-15 | 0d | 809d |  | finish no earlier than 2024-11-15 | SIT | 15.33 | 6.11 | Green | GREEN |
| 1170 | 1.4.1.4.5.3.3.3 | **Major Incident Management Build & Configuration Complete** | 75d? | 2024-10-02 | 2025-01-14 | 2024-10-02 | 2025-01-14 | 0d |  |  |  | SIT | -728.67 | 6.11 | Overdue Start |  |
| 1171 | 1.4.1.4.5.3.3.3.1 | Build | 1d? | 2024-11-26 | 2024-11-26 | 2024-11-26 | 2024-11-26 | 0d | 802d |  | finish no earlier than 2024-11-26 | SIT | 26.33 | 6.11 | Green | GREEN |
| 1172 | 1.4.1.4.5.3.3.3.2 | Test | 1d? | 2024-12-17 | 2024-12-17 | 2024-12-17 | 2024-12-17 | 0d | 787d |  | finish no earlier than 2024-12-17 | SIT | 47.33 | 6.11 | Green | GREEN |
| 1173 | 1.4.1.4.5.3.3.3.3 | Deploy | 1d? | 2025-01-14 | 2025-01-14 | 2025-01-14 | 2025-01-14 | 0d | 767d |  | finish no earlier than 2025-01-14 | SIT | 75.33 | 6.11 | Green | GREEN |
| 1174 | 1.4.1.4.5.3.3.4 | **Knowledge Management Build & Configuration Complete** | 75d? | 2024-10-02 | 2025-01-14 | 2024-10-02 | 2025-01-14 | 0d |  |  |  | SIT | -728.67 | 6.11 | Overdue Start |  |
| 1175 | 1.4.1.4.5.3.3.4.1 | Build | 1d? | 2024-11-26 | 2024-11-26 | 2024-11-26 | 2024-11-26 | 0d | 802d |  | finish no earlier than 2024-11-26 | SIT | 26.33 | 6.11 | Green | GREEN |
| 1176 | 1.4.1.4.5.3.3.4.2 | Test | 1d? | 2024-12-17 | 2024-12-17 | 2024-12-17 | 2024-12-17 | 0d | 787d |  | finish no earlier than 2024-12-17 | SIT | 47.33 | 6.11 | Green | GREEN |
| 1177 | 1.4.1.4.5.3.3.4.3 | Deploy | 1d? | 2025-01-14 | 2025-01-14 | 2025-01-14 | 2025-01-14 | 0d | 767d |  | finish no earlier than 2025-01-14 | SIT | 75.33 | 6.11 | Green | GREEN |
| 1178 | 1.4.1.4.5.3.3.5 | **Problem Management Build Complete** | 75d? | 2024-10-02 | 2025-01-14 | 2024-10-02 | 2025-01-14 | 0d |  |  |  | SIT | -728.67 | 6.11 | Overdue Start |  |
| 1179 | 1.4.1.4.5.3.3.5.1 | Build | 1d? | 2024-11-26 | 2024-11-26 | 2024-11-26 | 2024-11-26 | 0d | 802d |  | finish no earlier than 2024-11-26 | SIT | 26.33 | 6.11 | Green | GREEN |
| 1180 | 1.4.1.4.5.3.3.5.2 | Test | 1d? | 2024-12-17 | 2024-12-17 | 2024-12-17 | 2024-12-17 | 0d | 787d |  | finish no earlier than 2024-12-17 | SIT | 47.33 | 6.11 | Green | GREEN |
| 1181 | 1.4.1.4.5.3.3.5.3 | Deploy | 1d? | 2025-01-14 | 2025-01-14 | 2025-01-14 | 2025-01-14 | 0d | 767d |  | finish no earlier than 2025-01-14 | SIT | 75.33 | 6.11 | Green | GREEN |
| 1182 | 1.4.1.4.5.3.3.6 | **Change Management Build & Configuration Complete** | 75d? | 2024-10-02 | 2025-01-14 | 2024-10-02 | 2025-01-14 | 0d |  |  |  | SIT | -728.67 | 6.11 | Overdue Start |  |
| 1183 | 1.4.1.4.5.3.3.6.1 | Build | 1d? | 2024-11-26 | 2024-11-26 | 2024-11-26 | 2024-11-26 | 0d | 802d |  | finish no earlier than 2024-11-26 | SIT | 26.33 | 6.11 | Green | GREEN |
| 1184 | 1.4.1.4.5.3.3.6.2 | Test | 1d? | 2024-12-17 | 2024-12-17 | 2024-12-17 | 2024-12-17 | 0d | 787d |  | finish no earlier than 2024-12-17 | SIT | 47.33 | 6.11 | Green | GREEN |
| 1185 | 1.4.1.4.5.3.3.6.3 | Deploy | 1d? | 2025-01-14 | 2025-01-14 | 2025-01-14 | 2025-01-14 | 0d | 767d |  | finish no earlier than 2025-01-14 | SIT | 75.33 | 6.11 | Green | GREEN |
| 1186 | 1.4.1.4.5.3.3.7 | **Service Catalogue Management Build & Configuration Complete** | 75d? | 2024-10-02 | 2025-01-14 | 2024-10-02 | 2025-01-14 | 0d |  |  |  | SIT | -728.67 | 6.11 | Overdue Start |  |
| 1187 | 1.4.1.4.5.3.3.7.1 | Build | 1d? | 2024-11-26 | 2024-11-26 | 2024-11-26 | 2024-11-26 | 0d | 802d |  | finish no earlier than 2024-11-26 | SIT | 26.33 | 6.11 | Green | GREEN |
| 1188 | 1.4.1.4.5.3.3.7.2 | Test | 1d? | 2024-12-17 | 2024-12-17 | 2024-12-17 | 2024-12-17 | 0d | 787d |  | finish no earlier than 2024-12-17 | SIT | 47.33 | 6.11 | Green | GREEN |
| 1189 | 1.4.1.4.5.3.3.7.3 | Deploy | 1d? | 2025-01-14 | 2025-01-14 | 2025-01-14 | 2025-01-14 | 0d | 767d |  | finish no earlier than 2025-01-14 | SIT | 75.33 | 6.11 | Green | GREEN |
| 1190 | 1.4.1.4.5.3.3.8 | Helix Engagement and Comms | 105d? | 2024-09-09 | 2025-01-31 | 2024-09-09 | 2025-01-31 | 0d | 115d | 0d | start no earlier than 2024-09-09 | SIT | -51.67 | 6.0 | Overdue Start | GREEN |

Notes:
- 1164: 29/11/24 - This section is still under development with the Elexon Helix team. Dates supplied by Elexon Helix and are indicative.
- 1165: 29/11/24 - This section is still under development with the Elexon Helix team. Dates supplied by Elexon Helix and are indicative.
- 1166: 29/11/24 - This section is still under development with the Elexon Helix team. Dates supplied by Elexon Helix and are indicative.
- 1167: 29/11/24 - This section is still under development with the Elexon Helix team. Dates supplied by Elexon Helix and are indicative.
- 1168: 29/11/24 - This section is still under development with the Elexon Helix team. Dates supplied by Elexon Helix and are indicative.
- 1169: 29/11/24 - This section is still under development with the Elexon Helix team. Dates supplied by Elexon Helix and are indicative.
- 1170: 29/11/24 - This section is still under development with the Elexon Helix team. Dates supplied by Elexon Helix and are indicative.
- 1171: 29/11/24 - This section is still under development with the Elexon Helix team. Dates supplied by Elexon Helix and are indicative.
- 1172: 29/11/24 - This section is still under development with the Elexon Helix team. Dates supplied by Elexon Helix and are indicative.
- 1173: 29/11/24 - This section is still under development with the Elexon Helix team. Dates supplied by Elexon Helix and are indicative.
- 1174: 29/11/24 - This section is still under development with the Elexon Helix team. Dates supplied by Elexon Helix and are indicative.
- 1175: 29/11/24 - This section is still under development with the Elexon Helix team. Dates supplied by Elexon Helix and are indicative.
- 1176: 29/11/24 - This section is still under development with the Elexon Helix team. Dates supplied by Elexon Helix and are indicative.
- 1177: 29/11/24 - This section is still under development with the Elexon Helix team. Dates supplied by Elexon Helix and are indicative.
- 1178: 29/11/24 - This section is still under development with the Elexon Helix team. Dates supplied by Elexon Helix and are indicative.
- 1179: 29/11/24 - This section is still under development with the Elexon Helix team. Dates supplied by Elexon Helix and are indicative.
- 1180: 29/11/24 - This section is still under development with the Elexon Helix team. Dates supplied by Elexon Helix and are indicative.
- 1181: 29/11/24 - This section is still under development with the Elexon Helix team. Dates supplied by Elexon Helix and are indicative.
- 1182: 29/11/24 - This section is still under development with the Elexon Helix team. Dates supplied by Elexon Helix and are indicative.
- 1183: 29/11/24 - This section is still under development with the Elexon Helix team. Dates supplied by Elexon Helix and are indicative.
- 1184: 29/11/24 - This section is still under development with the Elexon Helix team. Dates supplied by Elexon Helix and are indicative.
- 1185: 29/11/24 - This section is still under development with the Elexon Helix team. Dates supplied by Elexon Helix and are indicative.
- 1186: 29/11/24 - This section is still under development with the Elexon Helix team. Dates supplied by Elexon Helix and are indicative.
- 1187: 29/11/24 - This section is still under development with the Elexon Helix team. Dates supplied by Elexon Helix and are indicative.
- 1188: 29/11/24 - This section is still under development with the Elexon Helix team. Dates supplied by Elexon Helix and are indicative.
- 1189: 29/11/24 - This section is still under development with the Elexon Helix team. Dates supplied by Elexon Helix and are indicative.
- 1190: 29/11/24 - This section is still under development with the Elexon Helix team. Dates supplied by Elexon Helix and are indicative.

| ID | WBS | Task | Type | Duration | Start | Finish | Predecessors | Complete | Remaining | Baseline start | Baseline finish | Baseline duration | Total slack | Free slack | Constraint | Baseline cost | Text9 | Task Status | Update Version | Sched Status | RAG | Responsible | Involved | MHHS Resource Name | MHHS Programme Phase |
| --- | --- | --- | --- | --- | --- | --- | --- | --- | --- | --- | --- | --- | --- | --- | --- | --- | --- | --- | --- | --- | --- | --- | --- | --- | --- |
| 1191 | 1.4.1.4.5.3.3.9 | **Helix Service Management Documentation (Service Design Pack)** |  | 102d | 2024-08-01 | 2024-12-20 |  |  |  | 2024-09-09 | 2025-01-31 | 0d | 145d | 30d |  |  | SIT | -49.67 | 6.0 | Overdue Start |  |  |  |  |  |
| 1192 | 1.4.1.4.5.3.3.9.1 | Document Drafting |  | 95d | 2024-08-01 | 2024-12-11 |  |  |  | 2024-08-01 | 2024-12-11 | 0d | 149d | 0d | finish no earlier than 2024-12-11 |  | SIT | -90.67 | 6.11 | Overdue Start | GREEN |  |  |  |  |
| 1193 | 1.4.1.4.5.3.3.9.2 | Internal Elexon Review |  | 3d | 2024-12-12 | 2024-12-16 | 1192 |  |  | 2024-12-12 | 2024-12-16 | 0d | 149d |  | finish no earlier than 2024-12-16 |  | SIT | 42.33 | 6.11 | Green | GREEN |  |  |  |  |
| 1194 | 1.4.1.4.5.3.3.9.3 | Elexon Service Panel Review |  | 5d | 2024-12-16 | 2024-12-20 |  |  |  | 2024-12-16 | 2024-12-20 | 0d | 145d | 0d | finish no earlier than 2024-12-20 |  | SIT | 46.33 | 6.11 | Green | GREEN |  |  |  |  |
| 1195 | 1.4.1.4.5.3.3.9.4 | Elexon Service Panel Sign off | milestone | 0d | 2024-12-20 | 2024-12-20 | 1194 |  |  | 2024-12-20 | 2024-12-20 | 0d | 145d |  | start no earlier than 2024-12-20 |  | SIT | 50.71 | 6.11 | Green | GREEN |  |  |  |  |
| 1196 | 1.4.1.4.5.3.3.10 | **Helix Service Management Documentation (Service User Op Model)** |  | 79d | 2024-10-16 | 2025-02-03 |  |  |  | 2024-10-16 | 2025-02-03 | 0d | 753d |  |  |  | SIT | -728.67 | 6.11 | Overdue Start |  |  |  |  |  |
| 1197 | 1.4.1.4.5.3.3.10.1 | Creation of Operations Manual Template |  | 8d | 2024-10-16 | 2024-10-25 |  |  |  | 2024-10-16 | 2024-10-25 | 0d | 824d |  | start no earlier than 2024-10-16 |  | SIT | -14.67 | 6.11 | Overdue Start | GREEN |  |  |  |  |
| 1198 | 1.4.1.4.5.3.3.10.2 | External Participant Workshops |  | 25d | 2024-11-20 | 2024-12-24 |  |  |  | 2024-11-20 | 2024-12-24 | 0d | 782d |  | start no earlier than 2024-11-20 |  | SIT | 20.33 | 6.11 | Green | GREEN |  |  |  |  |
| 1199 | 1.4.1.4.5.3.3.10.3 | 1st Draft of Operations Manual |  | 5d | 2024-11-27 | 2024-12-03 |  |  |  | 2024-11-27 | 2024-12-03 | 0d | 797d |  | start no earlier than 2024-11-27 |  | SIT | 27.33 | 6.11 | Green | GREEN |  |  |  |  |
| 1200 | 1.4.1.4.5.3.3.10.4 | November TOWRG (Update) | milestone | 0d | 2024-11-14 | 2024-11-14 |  |  |  | 2024-11-14 | 2024-11-14 | 0d | 811d |  | start no earlier than 2024-11-14 |  | SIT | 14.33 | 6.11 | Green | GREEN |  |  |  |  |
| 1201 | 1.4.1.4.5.3.3.10.5 | December TOWRG | milestone | 0d | 2024-12-11 | 2024-12-11 |  |  |  | 2024-12-11 | 2024-12-11 | 0d | 792d |  | start no earlier than 2024-12-11 |  | SIT | 41.33 | 6.11 | Green | GREEN |  |  |  |  |
| 1202 | 1.4.1.4.5.3.3.10.6 | Comments Addressed From 1st Draft |  | 20d | 2025-01-07 | 2025-02-03 |  |  |  | 2025-01-07 | 2025-02-03 | 0d | 753d |  | start no earlier than 2025-01-07 |  | SIT | 68.33 | 6.11 | Green | GREEN |  |  |  |  |
| 1203 | 1.4.1.4.5.3.3.10.7 | Final Version of Operations Manual |  | 5d | 2025-01-14 | 2025-01-20 |  |  |  | 2025-01-14 | 2025-01-20 | 0d | 763d |  | start no earlier than 2025-01-14 |  | SIT | 75.33 | 6.11 | Green | GREEN |  |  |  |  |
| 1204 | 1.4.1.4.5.3.3.10.8 | January TOWRG Operations Manual agreement |  | 5d | 2025-01-21 | 2025-01-27 |  |  |  | 2025-01-21 | 2025-01-27 | 0d | 758d |  | start no earlier than 2025-01-21 |  | SIT | 82.33 | 6.11 | Green | GREEN |  |  |  |  |
| 1205 | 1.4.1.4.5.3.3.10.9 | January MCAG Endorsement | milestone | 0d | 2025-01-21 | 2025-01-21 |  |  |  | 2025-01-21 | 2025-01-21 | 0d | 763d |  | start no earlier than 2025-01-21 |  | SIT | 82.33 | 6.11 | Green | GREEN |  |  |  |  |
| 1206 | 1.4.1.4.5.3.3.11 | Helix Knowledge Articles |  | 105d? | 2024-09-09 | 2025-01-31 |  |  |  | 2024-09-09 | 2025-01-31 | 0d | 115d | 0d | start no earlier than 2024-09-09 |  | SIT | -51.67 | 6.0 | Overdue Start | GREEN |  |  |  |  |
| 1207 | 1.4.1.4.5.3.4 | **Theme 3 (Batch 2)** |  | 60d? | 2024-09-19 A | 2024-12-11 |  | 26% | 44.65d? | 2024-09-19 | 2024-12-11 | 116d | 791d |  |  | -0 | SIT | -448.67 | 6.0 |  |  | N/A | N/A | N/A | Systems Integration Testing (SIT) |
| 1208 | 1.4.1.4.5.3.4.1 | Conclude BCDR Scope with SRO, Code Bodies and DIP Manager |  | 22d | 2024-09-19 A | 2024-10-18 |  | 50% | 11d | 2024-09-19 | 2024-10-18 | 0d | 829d |  | start no earlier than 2024-09-19 |  | SIT |  | 6.0 | Overdue | RED |  |  |  |  |
| 1209 | 1.4.1.4.5.3.4.2 | Develop BDCR Test Scenarios & Test Cases (Batch 2) |  | 10d | 2024-10-14 A | 2024-10-25 A | 1208 | 100% |  | 2024-10-14 | 2024-10-25 | 0d |  |  |  |  | SIT |  | 6.0 | Complete | COMPLETE |  |  |  |  |
| 1210 | 1.4.1.4.5.3.4.3 | Develop DIP Test Scenarios and Test Cases (Batch 2) |  | 27d | 2024-09-19 | 2024-10-25 |  |  |  | 2024-09-19 | 2024-10-25 | 0d | 1d | 0d | start no earlier than 2024-09-19 |  | SIT | -41.67 | 6.0 | Overdue Start | GREEN |  |  |  |  |
| 1211 | 1.4.1.4.5.3.4.4 | SRO Review |  | 5d | 2024-10-28 | 2024-11-01 | 1210 |  |  | 2024-10-28 | 2024-11-01 | 0d | 1d | 0d | start no earlier than 2024-10-28 |  | SIT | -2.67 | 6.0 | Green | GREEN |  |  |  |  |
| 1212 | 1.4.1.4.5.3.4.5 | Industry Review Workshop (Batch 2) |  | 10d | 2024-11-04 A | 2024-11-15 | 1211 | 10% | 9d | 2024-11-04 | 2024-11-15 | 1d | 94d | 0d |  |  | SIT |  | 6.0 | Green | GREEN | SI Test, PP | SI Test, PP |  |  |
| 1213 | 1.4.1.4.5.3.4.6 | Review Feedback and Update |  | 5d | 2024-11-18 | 2024-11-22 | 1212 |  |  | 2024-11-18 | 2024-11-22 | 0d | 94d | 0d |  |  | SIT | 18.33 | 6.0 | Green | GREEN |  |  |  |  |
| 1214 | 1.4.1.4.5.3.4.7 | Review with SIT WG (Batch 2) |  | 6d | 2024-11-28 | 2024-12-05 | 1213FS+3d |  |  | 2024-11-28 | 2024-12-05 | 0d | 94d | 0d |  |  | SIT | 28.33 | 6.0 | Green | GREEN |  |  |  |  |
| 1215 | 1.4.1.4.5.3.4.8 | SITAG Approval (Batch 2) |  | 1d? | 2024-12-11 | 2024-12-11 | 1214FS+3d |  |  | 2024-12-11 | 2024-12-11 | 0d | 94d | 0d |  |  | SIT | 41.33 | 6.0 | Green | GREEN |  |  |  |  |

Notes:
- 1191: 29/11/24 - This section is still under development with the Elexon Helix team. Dates supplied by Elexon Helix and are indicative.
- 1192: 29/11/24 - This section is still under development with the Elexon Helix team. Dates supplied by Elexon Helix and are indicative.
- 1193: 29/11/24 - This section is still under development with the Elexon Helix team. Dates supplied by Elexon Helix and are indicative.
- 1194: 29/11/24 - This section is still under development with the Elexon Helix team. Dates supplied by Elexon Helix and are indicative.
- 1195: 29/11/24 - This section is still under development with the Elexon Helix team. Dates supplied by Elexon Helix and are indicative.
- 1196: 29/11/24 - This section is still under development with the Elexon Helix team. Dates supplied by Elexon Helix and are indicative.
- 1197: 29/11/24 - This section is still under development with the Elexon Helix team. Dates supplied by Elexon Helix and are indicative.
- 1198: 29/11/24 - This section is still under development with the Elexon Helix team. Dates supplied by Elexon Helix and are indicative.
- 1199: 29/11/24 - This section is still under development with the Elexon Helix team. Dates supplied by Elexon Helix and are indicative.
- 1200: 29/11/24 - This section is still under development with the Elexon Helix team. Dates supplied by Elexon Helix and are indicative.
- 1201: 29/11/24 - This section is still under development with the Elexon Helix team. Dates supplied by Elexon Helix and are indicative.
- 1202: 29/11/24 - This section is still under development with the Elexon Helix team. Dates supplied by Elexon Helix and are indicative.
- 1203: 29/11/24 - This section is still under development with the Elexon Helix team. Dates supplied by Elexon Helix and are indicative.
- 1204: 29/11/24 - This section is still under development with the Elexon Helix team. Dates supplied by Elexon Helix and are indicative.
- 1205: 29/11/24 - This section is still under development with the Elexon Helix team. Dates supplied by Elexon Helix and are indicative.
- 1206: 29/11/24 - This section is still under development with the Elexon Helix team. Dates supplied by Elexon Helix and are indicative.
- 1209: 12/09/24 - Added new milestone for Batch 2
- 1212: 12/09/24 - Forecast date changed in line with SI Plan.

| ID | WBS | Task | Type | Duration | Start | Finish | Predecessors | Complete | Remaining | Baseline start | Baseline finish | Baseline duration | Baseline 1 start | Baseline 1 finish | Total slack | Free slack | Constraint | Baseline cost | Text9 | Task Status | Update Version | Sched Status | RAG | Responsible | Involved | Guidance | MHHS Resource Name | MHHS Programme Phase | Milestone ID | Text29 |
| --- | --- | --- | --- | --- | --- | --- | --- | --- | --- | --- | --- | --- | --- | --- | --- | --- | --- | --- | --- | --- | --- | --- | --- | --- | --- | --- | --- | --- | --- | --- |
| 1216 | 1.4.1.4.5.3.5 | **Theme 3 (Batch 1)** |  | 176d? | 2024-04-10 A | 2024-12-11 |  | 75% | 44.33d? | 2024-04-10 | 2024-12-11 | 0d |  |  | 94d |  |  |  | SIT | -688.67 | 6.0 | Overdue Start | RED |  |  |  |  |  |  |  |
| 1217 | 1.4.1.4.5.3.5.1 | Develop Test Scenarios & Test Cases (Batch 1) |  | 78d | 2024-04-10 A | 2024-07-26 A | 1144 | 100% |  | 2024-04-10 | 2024-07-26 | 46d |  |  |  |  |  |  | SIT |  | 6.0 | Complete | COMPLETE | SI Test | SI Test, PP |  |  |  |  |  |
| 1218 | 1.4.1.4.5.3.5.2 | Conclude Industry Consultation (Batch 1) |  | 11d | 2024-09-05 A | 2024-09-19 A |  | 100% |  | 2024-09-05 | 2024-09-19 | 0d |  |  |  |  | start no earlier than 2024-09-05 |  | SIT |  | 6.0 | Complete | COMPLETE |  |  |  |  |  |  |  |
| 1219 | 1.4.1.4.5.3.5.3 | Review Feedback and Update |  | 5d | 2024-09-20 A | 2024-09-26 | 1218 | 90% | 0.5d | 2024-09-20 | 2024-09-26 | 0d |  |  | 7.5d | 0d |  |  | SIT |  | 6.0 | Overdue | RED |  |  |  |  |  |  |  |
| 1220 | 1.4.1.4.5.3.5.4 | Draft Test Cases from Feedback and LLSD |  | 15d? | 2024-09-30 A | 2024-10-18 | 1219FS+1d, 1229 | 50% | 7.5d? | 2024-09-30 | 2024-10-18 | 0d |  |  | 94d | 0d |  |  | SIT |  | 6.0 | Overdue | RED |  |  |  |  |  |  |  |
| 1221 | 1.4.1.4.5.3.5.5 | SRO Review |  | 5d? | 2024-10-21 | 2024-10-25 | 1220 |  |  | 2024-10-21 | 2024-10-25 | 0d |  |  | 94d | 0d |  |  | SIT | -9.67 | 6.0 | Overdue Start | GREEN |  |  |  |  |  |  |  |
| 1222 | 1.4.1.4.5.3.5.6 | Industry Consultation |  | 10d? | 2024-10-28 | 2024-11-08 | 1221 |  |  | 2024-10-28 | 2024-11-08 | 0d |  |  | 94d | 0d |  |  | SIT | -2.67 | 6.0 | Green | GREEN |  |  |  |  |  |  |  |
| 1223 | 1.4.1.4.5.3.5.7 | Review Feedback and Update |  | 5d | 2024-11-11 | 2024-11-15 | 1222 |  |  | 2024-11-11 | 2024-11-15 | 0d |  |  | 94d | 0d |  |  | SIT | 11.33 | 6.0 | Green | GREEN |  |  |  |  |  |  |  |
| 1224 | 1.4.1.4.5.3.5.8 | Review with SITWG (Batch 1) |  | 5d? | 2024-11-28 | 2024-12-04 | 1223FS+8d |  |  | 2024-11-28 | 2024-12-04 | 0d |  |  | 94d | 0d |  |  | SIT | 28.33 | 6.0 | Green | GREEN |  |  |  |  |  |  |  |
| 1225 | 1.4.1.4.5.3.5.9 | SITAG for approval (Batch 1) |  | 1d | 2024-12-11 | 2024-12-11 | 1224FS+4d |  |  | 2024-12-11 | 2024-12-11 | 0d |  |  | 94d | 0d |  |  | SIT | 41.33 | 6.0 | Green | GREEN |  |  |  |  |  |  |  |
| 1226 | 1.4.1.4.5.3.5.10 | SIT Operational Scenarios & Test Cases Approved - Theme 3 (Batch 1 + 2) | milestone | 0d | 2024-12-11 | 2024-12-11 | 1229, 1215, 1225 |  |  | 2024-12-11 | 2024-12-11 | 0d |  |  | 94d | 0d |  |  | SIT | 41.71 | 6.0 | Green | AMBER | SI Test | SI Test, PP | 31/7/24: baseline date change approved at esitag on 26/7/24 | Roger Robar | Systems Integration Testing (SIT) | T3-TE-0119 | SITAG |
| 1227 | 1.4.1.4.5.3.6 | **Helix SDD and LLSD Development and Approval** |  | 1d | 2024-09-27 A | 2024-09-30 A |  | 100% |  | 2024-09-27 | 2024-09-30 | 0d |  |  |  |  |  |  | SIT | -688.67 | 6.0 | Overdue Start |  |  |  |  |  |  |  |  |
| 1228 | 1.4.1.4.5.3.6.1 | Development | milestone | 0d | 2024-09-27 A | 2024-09-27 A |  | 100% |  | 2024-09-27 | 2024-09-27 | 0d |  |  |  |  | start no earlier than 2024-09-27 |  | SIT |  | 6.0 | Complete | COMPLETE |  |  |  |  |  |  |  |
| 1229 | 1.4.1.4.5.3.6.2 | Approval | milestone | 0d | 2024-09-30 A | 2024-09-30 A |  | 100% |  | 2024-09-30 | 2024-09-30 | 0d |  |  |  |  | start no earlier than 2024-09-30 |  | SIT |  | 6.0 | Complete | COMPLETE |  |  |  |  |  |  |  |
| 1230 | 1.4.1.4.5.4 | **SIT Operational Programme RTTM** |  | 27d? | 2024-12-12 | 2025-01-17 |  |  |  | 2024-12-12 | 2025-01-17 | 0d |  |  | 764d |  |  |  | SIT | -686.67 | 6.0 | Overdue Start |  |  |  |  |  |  |  |  |
| 1231 | 1.4.1.4.5.4.1 | Develop Manual SIT Operational RTTM |  | 22d? | 2024-12-12 | 2025-01-10 | 1226 |  |  | 2024-12-12 | 2025-01-10 | 0d |  |  | 764d | 0d |  |  | SIT | 42.33 | 6.0 | Green | GREEN |  |  |  |  |  |  |  |
| 1232 | 1.4.1.4.5.4.2 | Manual SIT Operational RTTM Complete | milestone | 0d | 2025-01-10 | 2025-01-10 | 1231 |  |  | 2025-01-10 | 2025-01-10 | 0d |  |  | 769d |  |  |  | SIT | 71.71 | 6.0 | Green | GREEN |  |  |  |  |  |  |  |
| 1233 | 1.4.1.4.5.4.3 | Develop Automated SIT Operational RTTM |  | 5d | 2025-01-13 | 2025-01-17 | 1231 |  |  | 2025-01-13 | 2025-01-17 | 0d |  |  | 764d | 0d |  |  | SIT | 74.33 | 6.0 | Green | GREEN |  |  |  |  |  |  |  |
| 1234 | 1.4.1.4.5.4.4 | Automated SIT Operational RTTM Complete | milestone | 0d | 2025-01-17 | 2025-01-17 | 1233 |  |  | 2025-01-17 | 2025-01-17 | 0d |  |  | 764d |  |  |  | SIT | 78.71 | 6.0 | Green | GREEN |  |  |  |  |  |  |  |
| 1235 | 1.4.1.4.5.5 | **Environments (SIT B)** |  | 0d | 2024-10-07 | 2024-10-07 |  |  |  | 2024-10-07 | 2024-10-07 | 0d | 2024-09-03 | 2024-09-09 | 60d |  |  | -0 | SIT |  | 5.0 |  |  | N/A | N/A |  | N/A | Systems Integration Testing (SIT) |  |  |
| 1236 | 1.4.1.4.5.5.1 | **PP Environments (SIT B)** |  | 0d | 2024-10-07 | 2024-10-07 |  |  |  | 2024-10-07 | 2024-10-07 | 0d | 2024-09-03 | 2024-09-09 | 60d |  |  | -0 | SIT |  | 5.0 |  |  | N/A | N/A |  | N/A | Systems Integration Testing (SIT) |  |  |
| 1237 | 1.4.1.4.5.5.1.1 | Deployment of MHHS solution code to SIT B environments | milestone | 0d | 2024-10-07 | 2024-10-07 | 141 |  |  | 2024-10-07 | 2024-10-07 | 0d | 2024-09-03 | 2024-09-09 | 60d | 0d | start no earlier than 2024-08-27 |  | SIT | -23.67 | 5.21 | Overdue Start | RED | PP | SI Test |  | Heath Thomas | Systems Integration Testing (SIT) |  |  |
| 1238 | 1.4.1.4.5.5.2 | **SI Environments (SIT B)** |  | 0d | 2024-10-07 | 2024-10-07 |  |  |  | 2024-10-07 | 2024-10-07 | 0d | 2024-09-03 | 2024-09-09 | 60d |  |  | -0 | SIT |  | 5.0 |  |  | N/A | N/A |  | N/A | Systems Integration Testing (SIT) |  |  |
| 1239 | 1.4.1.4.5.5.2.1 | Coordinate deployment of MHHS solution code to SIT Participants' SIT B environments | milestone | 0d | 2024-10-07 | 2024-10-07 | 1237SS |  |  | 2024-10-07 | 2024-10-07 | 0d | 2024-09-03 | 2024-09-09 | 60d | 0d |  |  | SIT | -23.67 | 5.21 | Overdue Start | RED | SI Test | PP |  | Heath Thomas | Systems Integration Testing (SIT) |  |  |

Notes:
- 1217: 12/09/24 - Duration increased from 46 days to 78 days to reflect the SI Plan.
- 1226: Date missed. Still working LLSD feedback and clarifications requested. Once this has been completed, test cases can be drafted and submitted.

| ID | WBS | Task | Type | Duration | Start | Finish | Predecessors | Complete | Remaining | Baseline start | Baseline finish | Baseline duration | Baseline 1 start | Baseline 1 finish | Total slack | Free slack | Constraint | Baseline cost | Responsible | Involved | Text9 | Update Version | MHHS Resource Name | MHHS Programme Phase | Task Status | Sched Status | RAG | Milestone ID | Text29 | Tier | Programme Governance Forum responsible for decisio |
| --- | --- | --- | --- | --- | --- | --- | --- | --- | --- | --- | --- | --- | --- | --- | --- | --- | --- | --- | --- | --- | --- | --- | --- | --- | --- | --- | --- | --- | --- | --- | --- |
| 1240 | 1.4.1.4.6 | **SIT Operational Test Readiness Report** |  | 33d | 2024-08-05 | 2024-09-18 |  |  |  | 2024-08-05 | 2024-09-18 | 151d | 2025-01-07 | 2025-03-03 |  |  |  | -0 | N/A | N/A | SIT | 6.0 | N/A | Systems Integration Testing (SIT) |  |  |  |  |  |  |  |
| 1241 | 1.4.1.4.6.1 | **PP SIT Operational Test Readiness Report** |  | 0d | 2024-08-05 | 2024-08-05 |  |  |  | 2024-08-05 | 2024-08-05 | 131d | 2025-01-07 | 2025-02-17 |  |  |  | -0 | N/A | N/A | SIT | 6.11 | N/A | Systems Integration Testing (SIT) |  |  |  |  |  |  |  |
| 1242 | 1.4.1.4.6.1.1 | Test Readiness Report submitted to Programme for assurance | milestone | 0d | 2024-12-20 | 2024-12-20 | 406FF |  |  | 2024-08-05 | 2024-08-05 | 20d | 2025-01-07 | 2025-02-03 | 769d | 0d |  |  | PP | SI Test | SIT | 6.11 | Roger Robar | Systems Integration Testing (SIT) | 50.71 | Red | RED |  |  |  |  |
| 1243 | 1.4.1.4.6.2 | **SI SIT Operational Test Readiness Report** |  | 35d | 2024-12-02 | 2025-01-17 |  |  |  | 2024-08-05 | 2025-01-17 | 40d | 2025-01-07 | 2025-03-03 | 67d |  |  |  | N/A | N/A | SIT | 6.11 | N/A | Systems Integration Testing (SIT) |  |  |  |  |  |  |  |
| 1244 | 1.4.1.4.6.2.1 | Assure Test Participants' Test Readiness Reports |  | 15d | 2024-12-23 | 2025-01-10 | 1242 |  |  | 2024-08-05 | 2025-01-10 | 35d | 2025-01-07 | 2025-02-24 | 769d |  |  |  | SI Test | PP,IPA | SIT | 6.11 | Roger Robar | Systems Integration Testing (SIT) | 53.33 | Green | GREEN |  |  |  |  |
| 1245 | 1.4.1.4.6.2.2 | Develop Overarching SIT Operational Test Readiness Report |  | 30d | 2024-12-02 | 2025-01-10 |  |  |  | 2024-12-02 | 2025-01-10 | 20d | 2025-01-28 | 2025-02-24 | 67d | 0d | start no earlier than 2024-12-02 |  | SI Test |  | SIT | 6.0 | Roger Robar | Systems Integration Testing (SIT) | 32.33 | Green | GREEN |  |  |  |  |
| 1246 | 1.4.1.4.6.2.3 | Artefact review (via SITAG) and updates |  | 5d | 2025-01-13 | 2025-01-17 | 1245 |  |  | 2025-01-13 | 2025-01-17 | 5d | 2025-02-25 | 2025-03-03 | 67d | 0d |  |  | SI Test | PP,IPA | SIT | 5.0 | Roger Robar | Systems Integration Testing (SIT) | 74.33 | Green | GREEN |  |  |  |  |
| 1247 | 1.4.1.4.6.3 | SIT Operational Testing Preparation Complete | milestone | 0d | 2025-01-17 | 2025-01-17 | 406, 1157, 1163, 1226, 1246 |  |  | 2025-01-17 | 2025-01-17 | 0d | 2025-03-10 | 2025-03-10 | 67d | 7d | finish no earlier than 2024-10-04 |  | SI Test | PP,IPA | SIT | 6.0 | Roger Robar | Systems Integration Testing (SIT) | 78.71 | Green | GREEN | T2-TE-0750 | SITAG | T2 |  |
| 1248 | 1.4.1.4.7 | **Regression Test Preparation** |  | 175d? | 2024-09-16 A | 2025-05-16 |  | 3% | 169.73d? | 2024-09-16 | 2025-05-16 | 0d |  |  | 679d |  |  |  |  |  | SIT | 6.1 | Roger Robar |  | -686.67 | Overdue Start | RED |  |  |  |  |
| 1249 | 1.4.1.4.7.1 | **Regression Test Approach** |  | 48d | 2024-09-16 A | 2024-11-20 |  | 7% | 44.48d | 2024-09-16 | 2024-11-20 | 0d |  |  | 119d |  |  |  |  |  | SIT | 6.1 | Roger Robar |  | -686.67 | Overdue Start | RED |  |  |  |  |
| 1250 | 1.4.1.4.7.1.1 | Develop approach doc |  | 22d | 2024-09-16 A | 2024-10-15 |  | 10% | 19.8d | 2024-09-16 | 2024-10-15 | 0d |  |  | 119d | 0d | start no earlier than 2024-09-16 |  |  |  | SIT | 6.1 | Roger Robar |  |  | Overdue | RED |  |  |  |  |
| 1251 | 1.4.1.4.7.1.2 | SRO review of approach doc |  | 3d | 2024-10-16 | 2024-10-18 | 1250 |  |  | 2024-10-16 | 2024-10-18 | 0d |  |  | 119d | 0d |  |  |  |  | SIT | 6.1 | Roger Robar |  | -14.67 | Overdue Start | RED |  |  |  |  |
| 1252 | 1.4.1.4.7.1.3 | SITWG feedback on approach doc |  | 2d | 2024-10-28 | 2024-10-29 | 1251FS+5d |  |  | 2024-10-28 | 2024-10-29 | 0d |  |  | 119d | 0d |  |  |  |  | SIT | 6.1 | Roger Robar |  | -2.67 | Green | GREEN |  |  |  |  |
| 1253 | 1.4.1.4.7.1.4 | Incorporate SRO + SITWG feedback into approach doc |  | 2d | 2024-10-30 | 2024-10-31 | 1252 |  |  | 2024-10-30 | 2024-10-31 | 0d |  |  | 119d | 0d |  |  |  |  | SIT | 6.1 | Roger Robar |  | -0.67 | Green | GREEN |  |  |  |  |
| 1254 | 1.4.1.4.7.1.5 | SITWG Recommendation |  | 1d | 2024-11-07 | 2024-11-07 | 1253FS+4d |  |  | 2024-11-07 | 2024-11-07 | 0d |  |  | 119d | 0d |  |  |  |  | SIT | 6.1 | Roger Robar |  | 7.33 | Green | GREEN |  |  |  |  |
| 1255 | 1.4.1.4.7.1.6 | SITAG (inc SRO) Approval | milestone | 0d | 2024-11-20 | 2024-11-20 | 1254FS+9d |  |  | 2024-11-20 | 2024-11-20 | 0d |  |  | 119d | 0d |  |  |  |  | SIT | 6.1 | Roger Robar |  | 20.71 | Green | GREEN |  |  |  |  |
| 1256 | 1.4.1.4.7.1.7 | SIT Regression Testing Approach and Plan Approval | milestone | 0d | 2024-11-20 | 2024-11-20 | 1255 |  |  | 2024-11-20 | 2024-11-20 | 0d |  |  | 119d | 0d |  |  |  |  | SIT | 6.1 | Roger Robar |  | 20.71 | Green | GREEN | T3-TE-0123 |  |  |  |
| 1257 | 1.4.1.4.7.2 | **Regression Test Suite** |  | 38d? | 2024-11-21 | 2025-01-13 |  |  |  | 2024-11-21 | 2025-01-13 | 0d |  |  | 119d |  |  |  |  |  | SIT | 6.1 | Roger Robar |  | -686.67 | Overdue Start | RED |  |  |  |  |
| 1258 | 1.4.1.4.7.2.1 | Build Regression Test Suite |  | 12d | 2024-11-21 | 2024-12-06 | 1256 |  |  | 2024-11-21 | 2024-12-06 | 0d |  |  | 119d | 0d |  |  |  |  | SIT | 6.1 | Roger Robar |  | 21.33 | Green | GREEN |  |  |  |  |
| 1259 | 1.4.1.4.7.2.2 | SRO Review of regression suite doc |  | 10d | 2024-12-09 | 2024-12-20 | 1258 |  |  | 2024-12-09 | 2024-12-20 | 0d |  |  | 119d | 0d |  |  |  |  | SIT | 6.1 | Roger Robar |  | 39.33 | Green | GREEN |  |  |  |  |
| 1260 | 1.4.1.4.7.2.3 | SITWG Feedback on regression suite doc |  | 5d | 2024-12-30 | 2025-01-03 | 1259FS+5d |  |  | 2024-12-30 | 2025-01-03 | 0d |  |  | 119d | 0d |  |  |  |  | SIT | 6.1 | Roger Robar |  | 60.33 | Green | GREEN |  |  |  |  |
| 1261 | 1.4.1.4.7.2.4 | Incorporate SRO + SITWG feedback into regression suite doc |  | 1d? | 2025-01-06 | 2025-01-06 | 1260 |  |  | 2025-01-06 | 2025-01-06 | 0d |  |  | 119d | 0d |  |  |  |  | SIT | 6.1 | Roger Robar |  | 67.33 | Green | GREEN |  |  |  |  |
| 1262 | 1.4.1.4.7.2.5 | SRO Approval | milestone | 0d | 2025-01-06 | 2025-01-06 | 1261 |  |  | 2025-01-06 | 2025-01-06 | 0d |  |  | 119d | 0d |  |  |  |  | SIT | 6.1 | Roger Robar |  | 67.71 | Green | GREEN |  |  |  |  |
| 1263 | 1.4.1.4.7.2.6 | SIT Regression Suite Approval at SITAG | milestone | 0d | 2025-01-13 | 2025-01-13 | 1262FS+5d |  |  | 2025-01-13 | 2025-01-13 | 0d |  |  | 768d |  |  |  |  |  | SIT | 6.1 | Roger Robar |  | 74.71 | Green | GREEN | T3-TE-0122 | SITAG |  | SITAG |

Notes:
- 1240: 12/09/24 - Forecast start date brought forward to 05/08/24, duration extended from 19 days to 33 days in line with the SI Plan.
- 1241: 12/09/24 - Forecast start date brought forward to 05/08/24 in line with the SI Plan.
- 1242: 12/09/24 - Forecast start date brought forward to 05/08/24 in line with the SI Plan.
- 1244: 12/09/24 - Duration increased from 5 days to 25 days in line with the SI Plan.
- 1245: 12/09/24 - Duration increased from 4 days to 18 days in line with the SI Plan.
- 1247: Date missed because of delay to submissions for SIT Operational PIT completion reports. Impact may be a delay to the start of SIT Operational Testing. Continue engagement with PPs.

| ID | WBS | Task | Type | Duration | Start | Finish | Predecessors | Complete | Remaining | Baseline start | Baseline finish | Baseline duration | Total slack | Free slack | Constraint | Text9 | Task Status | Update Version | Sched Status | MHHS Resource Name | RAG |
| --- | --- | --- | --- | --- | --- | --- | --- | --- | --- | --- | --- | --- | --- | --- | --- | --- | --- | --- | --- | --- | --- |
| 1264 | 1.4.1.4.7.3 | **Regression Test Data Load Window (SIT Functional and Migration) - SIT A** |  | 1d? | 2025-03-14 | 2025-03-17 |  |  |  | 2025-03-14 | 2025-03-17 | 0d |  |  |  | SIT | -686.67 | 6.1 | Overdue Start | Richard Puddephatt | RED |
| 1265 | 1.4.1.4.7.3.1 | Regression Test Data Load Start | milestone | 0d? | 2025-04-28 | 2025-04-28 | 1404, 1362FS+1d, 1408FS+1d |  |  | 2025-04-28 | 2025-04-28 | 0d | 5d | 0d |  | SIT | 179.71 | 6.1 | Green | Richard Puddephatt | GREEN |
| 1266 | 1.4.1.4.7.3.2 | Regression Test Data Load Window |  | 15d? | 2025-04-28 | 2025-05-16 | 1265FS-1d |  |  | 2025-04-28 | 2025-05-16 | 0d | 5d | 0d |  | SIT | 179.33 | 6.1 | Green | Richard Puddephatt | GREEN |
| 1267 | 1.4.1.4.8 | **Single Instance ADO** |  | 32d? | 2024-08-21 A | 2024-10-03 |  | 93% | 2.16d? | 2024-08-21 | 2024-10-03 | 0d | 840d |  |  | SIT | -701.67 | 6.1 | Overdue Start | Heath Thomas | RED |
| 1268 | 1.4.1.4.8.1 | **Single ADO Project for all Cohorts - Implementation and Test Phase** |  | 30d? | 2024-08-21 A | 2024-10-01 |  | 89% | 3.21d? | 2024-08-21 | 2024-10-01 | 0d | 842d |  |  | SIT | -701.67 | 6.1 | Overdue Start | Heath Thomas | RED |
| 1269 | 1.4.1.4.8.1.1 | Create test plans and suites in master project |  | 2d? | 2024-08-21 A | 2024-08-22 A |  | 100% |  | 2024-08-21 | 2024-08-22 | 0d |  |  | finish no earlier than 2024-08-22 | SIT |  | 6.1 | Complete |  | COMPLETE |
| 1270 | 1.4.1.4.8.1.2 | Create area paths / iterations |  | 2d? | 2024-08-21 A | 2024-08-22 A |  | 100% |  | 2024-08-21 | 2024-08-22 | 0d |  |  | finish no earlier than 2024-08-22 | SIT |  | 6.1 | Complete |  | COMPLETE |
| 1271 | 1.4.1.4.8.1.3 | Create IAM roles |  | 2d? | 2024-08-21 A | 2024-08-22 A |  | 100% |  | 2024-08-21 | 2024-08-22 | 0d |  |  | finish no earlier than 2024-08-22 | SIT |  | 6.1 | Complete |  | COMPLETE |
| 1272 | 1.4.1.4.8.1.4 | Add users to roles |  | 1d? | 2024-08-23 A | 2024-08-23 A |  | 100% |  | 2024-08-23 | 2024-08-23 | 0d |  |  | start no earlier than 2024-08-23 | SIT |  | 6.1 | Complete |  | COMPLETE |
| 1273 | 1.4.1.4.8.1.5 | **Testing permissions** |  | 2d? | 2024-08-27 A | 2024-08-28 A |  | 100% |  | 2024-08-27 | 2024-08-28 | 0d |  |  |  | SIT |  | 6.1 | Complete | Heath Thomas | COMPLETE |
| 1274 | 1.4.1.4.8.1.5.1 | Adding tests |  | 2d? | 2024-08-27 A | 2024-08-28 A |  | 100% |  | 2024-08-27 | 2024-08-28 | 0d |  |  | finish no earlier than 2024-08-28 | SIT |  | 6.1 | Complete |  | COMPLETE |
| 1275 | 1.4.1.4.8.1.5.2 | Deleting tests |  | 2d? | 2024-08-27 A | 2024-08-28 A |  | 100% |  | 2024-08-27 | 2024-08-28 | 0d |  |  | finish no earlier than 2024-08-28 | SIT |  | 6.1 | Complete |  | COMPLETE |
| 1276 | 1.4.1.4.8.1.5.3 | Adding tests to incorrect Cohort |  | 2d? | 2024-08-27 A | 2024-08-28 A |  | 100% |  | 2024-08-27 | 2024-08-28 | 0d |  |  | finish no earlier than 2024-08-28 | SIT |  | 6.1 | Complete |  | COMPLETE |
| 1277 | 1.4.1.4.8.1.5.4 | Add / delete defects |  | 2d? | 2024-08-27 A | 2024-08-28 A |  | 100% |  | 2024-08-27 | 2024-08-28 | 0d |  |  | finish no earlier than 2024-08-28 | SIT |  | 6.1 | Complete |  | COMPLETE |
| 1278 | 1.4.1.4.8.1.6 | Migrate defects from cohort project to master - Option 2 |  | 3d | 2024-09-23 | 2024-09-25 |  |  |  | 2024-09-23 | 2024-09-25 | 0d | 846d |  | start no earlier than 2024-09-23 | SIT | -37.67 | 6.1 | Overdue Start |  | RED |
| 1279 | 1.4.1.4.8.1.7 | Testing Permissions - Evidence attachment security |  | 10d? | 2024-09-18 A | 2024-10-01 A |  | 100% |  | 2024-09-18 | 2024-10-01 | 0d |  |  | finish no earlier than 2024-10-01 | SIT |  | 6.1 | Complete |  | COMPLETE |
| 1280 | 1.4.1.4.8.2 | **ADO Dashboard Updates** |  | 20d? | 2024-09-03 A | 2024-09-30 A |  | 100% |  | 2024-09-03 | 2024-09-30 | 0d |  |  |  | SIT | -701.67 | 6.1 | Overdue Start | Heath Thomas | RED |
| 1281 | 1.4.1.4.8.2.1 | Update reporting dashboards in ADO |  | 3d | 2024-09-03 A | 2024-09-05 A |  | 100% |  | 2024-09-03 | 2024-09-05 | 0d |  |  | start no earlier than 2024-09-03 | SIT |  | 6.1 | Complete |  | COMPLETE |
| 1282 | 1.4.1.4.8.2.2 | Review dashboards with SI LDP leads |  | 16d | 2024-09-06 A | 2024-09-27 A |  | 100% |  | 2024-09-06 | 2024-09-27 | 0d |  |  | start no earlier than 2024-09-06 | SIT |  | 6.1 | Complete |  | COMPLETE |
| 1283 | 1.4.1.4.8.2.3 | Review dashboards with SRO |  | 16d | 2024-09-09 A | 2024-09-30 A |  | 100% |  | 2024-09-09 | 2024-09-30 | 0d |  |  | start no earlier than 2024-09-09 | SIT |  | 6.1 | Complete |  | COMPLETE |
| 1284 | 1.4.1.4.8.2.4 | Update dashboards following review |  | 2d | 2024-09-12 A | 2024-09-13 A |  | 100% |  | 2024-09-12 | 2024-09-13 | 0d |  |  | start no earlier than 2024-09-12 | SIT |  | 6.1 | Complete |  | COMPLETE |
| 1285 | 1.4.1.4.8.2.5 | Document changes to dashboard creation process |  | 4d | 2024-09-16 A | 2024-09-19 A |  | 100% |  | 2024-09-16 | 2024-09-19 | 0d |  |  | start no earlier than 2024-09-16 | SIT |  | 6.1 | Complete |  | COMPLETE |
| 1286 | 1.4.1.4.8.2.6 | Update SIT Dashboards for Sprints 4.1 & 4.2 across all Cohorts |  | 1d? | 2024-09-03 A | 2024-09-03 A |  | 100% |  | 2024-09-03 | 2024-09-03 | 0d |  |  | start no earlier than 2024-09-03 | SIT |  | 6.1 | Complete |  | COMPLETE |
| 1287 | 1.4.1.4.8.3 | **Reporting Changes - PowerBI & QIP** |  | 23d? | 2024-08-23 A | 2024-09-24 |  | 70% | 6.9d? | 2024-08-23 | 2024-09-24 | 0d | 847d |  |  | SIT | -701.67 | 6.1 | Overdue Start | Heath Thomas |  |
| 1288 | 1.4.1.4.8.3.1 | Design, Create and ETL ADO Entities into PowerBI Data Model |  | 1d? | 2024-08-23 A | 2024-08-23 A |  | 100% |  | 2024-08-23 | 2024-08-23 | 0d |  |  | start no earlier than 2024-08-23 | SIT |  | 6.1 | Complete |  | COMPLETE |
| 1289 | 1.4.1.4.8.3.2 | Determine Relationships between ADO Entities & Attributes |  | 1d? | 2024-08-27 A | 2024-08-27 A |  | 100% |  | 2024-08-27 | 2024-08-27 | 0d |  |  | start no earlier than 2024-08-27 | SIT |  | 6.1 | Complete |  | COMPLETE |
| 1290 | 1.4.1.4.8.3.3 | Create Relevant Dax Measures |  | 1d? | 2024-08-28 A | 2024-08-28 A |  | 100% |  | 2024-08-28 | 2024-08-28 | 0d |  |  | start no earlier than 2024-08-28 | SIT |  | 6.1 | Complete |  | COMPLETE |
| 1291 | 1.4.1.4.8.3.4 | Design & Build Visualisations (Graphs) |  | 1d? | 2024-08-29 A | 2024-08-29 A |  | 100% |  | 2024-08-29 | 2024-08-29 | 0d |  |  | start no earlier than 2024-08-29 | SIT |  | 6.1 | Complete |  | COMPLETE |
| 1292 | 1.4.1.4.8.3.5 | Implement Filters |  | 1d? | 2024-09-23 A | 2024-09-23 A |  | 100% |  | 2024-09-23 | 2024-09-23 | 0d |  |  | start no earlier than 2024-09-23 | SIT |  | 6.1 | Complete |  | COMPLETE |
| 1293 | 1.4.1.4.8.3.6 | Check Data Quality & Integrity |  | 1d? | 2024-09-24 A | 2024-09-24 A |  | 100% |  | 2024-09-24 | 2024-09-24 | 0d |  |  | start no earlier than 2024-09-24 | SIT |  | 6.1 | Complete |  | COMPLETE |
| 1294 | 1.4.1.4.8.3.7 | Performance Optimisation |  | 1d? | 2024-09-24 A | 2024-09-24 A |  | 100% |  | 2024-09-24 | 2024-09-24 | 0d |  |  | start no earlier than 2024-09-24 | SIT |  | 6.1 | Complete |  | COMPLETE |
| 1295 | 1.4.1.4.8.3.8 | Publish (QIP) |  | 1d? | 2024-09-04 | 2024-09-04 |  |  |  | 2024-09-04 | 2024-09-04 | 0d | 861d |  | start no earlier than 2024-09-04 | SIT | -56.67 | 6.1 | Overdue Start |  | RED |
| 1296 | 1.4.1.4.8.3.9 | Review & UAT |  | 1d? | 2024-09-05 | 2024-09-05 |  |  |  | 2024-09-05 | 2024-09-05 | 0d | 860d |  | start no earlier than 2024-09-05 | SIT | -55.67 | 6.1 | Overdue Start |  | RED |
| 1297 | 1.4.1.4.8.3.10 | QIP Training Material & User Guides |  | 1d? | 2024-09-10 | 2024-09-10 |  |  |  | 2024-09-10 | 2024-09-10 | 0d | 857d |  | start no earlier than 2024-09-10 | SIT | -50.67 | 6.1 | Overdue Start |  | RED |

| ID | WBS | Task | Type | Duration | Start | Finish | Predecessors | Complete | Remaining | Baseline start | Baseline finish | Baseline duration | Baseline 1 start | Baseline 1 finish | Total slack | Constraint | Baseline cost | Text9 | Task Status | Update Version | Sched Status | MHHS Resource Name | RAG | Responsible | Involved | MHHS Programme Phase | Artefact ID | Milestone ID | Text29 | Tier | Text3 |
| --- | --- | --- | --- | --- | --- | --- | --- | --- | --- | --- | --- | --- | --- | --- | --- | --- | --- | --- | --- | --- | --- | --- | --- | --- | --- | --- | --- | --- | --- | --- | --- |
| 1298 | 1.4.1.4.8.4 | **Reporting Changes - Daily Excel Extract & PDF** |  | 2d | 2024-09-05 | 2024-09-06 |  |  |  | 2024-09-05 | 2024-09-06 | 0d |  |  | 859d |  |  | SIT | -701.67 | 6.1 | Overdue Start | Heath Thomas | RED |  |  |  |  |  |  |  |  |
| 1299 | 1.4.1.4.8.4.1 | Excel Daily Report changes (Refer to above) |  | 2d | 2024-09-05 | 2024-09-06 |  |  |  | 2024-09-05 | 2024-09-06 | 0d |  |  | 859d | start no earlier than 2024-09-05 |  | SIT | -55.67 | 6.1 | Overdue Start |  | RED |  |  |  |  |  |  |  |  |
| 1300 | 1.4.1.4.8.4.2 | PDF Daily Report changes (Refer to Above) |  | 2d | 2024-09-05 | 2024-09-06 |  |  |  | 2024-09-05 | 2024-09-06 | 0d |  |  | 859d | start no earlier than 2024-09-05 |  | SIT | -55.67 | 6.1 | Overdue Start |  | RED |  |  |  |  |  |  |  |  |
| 1301 | 1.4.1.4.8.5 | **Documentation Updates** |  | 23d? | 2024-09-02 A | 2024-10-02 A |  | 100% |  | 2024-09-02 | 2024-10-02 | 0d |  |  |  |  |  | SIT | -701.67 | 6.1 | Overdue Start | Heath Thomas |  |  |  |  |  |  |  |  |  |
| 1302 | 1.4.1.4.8.5.1 | Changes to onboarding process (security) |  | 10d | 2024-09-02 A | 2024-09-13 A |  | 100% |  | 2024-09-02 | 2024-09-13 | 0d |  |  |  | start no earlier than 2024-09-02 |  | SIT |  | 6.1 | Complete |  | COMPLETE |  |  |  |  |  |  |  |  |
| 1303 | 1.4.1.4.8.5.2 | Update the documents on loading tests into ADO? |  | 10d | 2024-09-02 A | 2024-09-13 A |  | 100% |  | 2024-09-02 | 2024-09-13 | 0d |  |  |  | start no earlier than 2024-09-02 |  | SIT |  | 6.1 | Complete |  | COMPLETE |  |  |  |  |  |  |  |  |
| 1304 | 1.4.1.4.8.5.3 | Update ADO Training material |  | 10d | 2024-09-02 A | 2024-09-13 A |  | 100% |  | 2024-09-02 | 2024-09-13 | 0d |  |  |  | start no earlier than 2024-09-02 |  | SIT |  | 6.1 | Complete |  | COMPLETE |  |  |  |  |  |  |  |  |
| 1305 | 1.4.1.4.8.5.4 | Update ADO User Guide |  | 10d | 2024-09-02 A | 2024-09-13 A |  | 100% |  | 2024-09-02 | 2024-09-13 | 0d |  |  |  | start no earlier than 2024-09-02 |  | SIT |  | 6.1 | Complete |  | COMPLETE |  |  |  |  |  |  |  |  |
| 1306 | 1.4.1.4.8.5.5 | Update ADO Configuration document |  | 10d | 2024-09-02 A | 2024-09-13 A |  | 100% |  | 2024-09-02 | 2024-09-13 | 0d |  |  |  | start no earlier than 2024-09-02 |  | SIT |  | 6.1 | Complete |  | COMPLETE |  |  |  |  |  |  |  |  |
| 1307 | 1.4.1.4.8.5.6 | Update ADO Training Material and User Guide following SRO review |  | 1d? | 2024-10-02 A | 2024-10-02 A |  | 100% |  | 2024-10-02 | 2024-10-02 | 0d |  |  |  | start no earlier than 2024-10-02 |  | SIT |  | 6.1 | Complete |  | COMPLETE |  |  |  |  |  |  |  |  |
| 1308 | 1.4.1.4.8.6 | **ADO Changes - Review Stage** |  | 19d? | 2024-09-09 A | 2024-10-03 A |  | 100% |  | 2024-09-09 | 2024-10-03 | 0d |  |  |  |  |  | SIT | -701.67 | 6.1 | Overdue Start | Heath Thomas |  |  |  |  |  |  |  |  |  |
| 1309 | 1.4.1.4.8.6.1 | Review implementation with SI LDP leads |  | 1d? | 2024-09-27 A | 2024-09-27 A |  | 100% |  | 2024-09-27 | 2024-09-27 | 0d |  |  |  | start no earlier than 2024-09-27 |  | SIT |  | 6.1 | Complete |  | COMPLETE |  |  |  |  |  |  |  |  |
| 1310 | 1.4.1.4.8.6.2 | Review implementation with SRO |  | 1d? | 2024-09-30 A | 2024-09-30 A |  | 100% |  | 2024-09-30 | 2024-09-30 | 0d |  |  |  | start no earlier than 2024-09-30 |  | SIT |  | 6.1 | Complete |  | COMPLETE |  |  |  |  |  |  |  |  |
| 1311 | 1.4.1.4.8.6.3 | LDP Review - ADO User Guide, Training Materials |  | 5d | 2024-09-09 A | 2024-09-13 A |  | 100% |  | 2024-09-09 | 2024-09-13 | 0d |  |  |  | start no earlier than 2024-09-09 |  | SIT |  | 6.1 | Complete |  | COMPLETE |  |  |  |  |  |  |  |  |
| 1312 | 1.4.1.4.8.6.4 | SRO Review - ADO User Guide, Training Materials |  | 1d? | 2024-09-30 A | 2024-09-30 A |  | 100% |  | 2024-09-30 | 2024-09-30 | 0d |  |  |  | start no earlier than 2024-09-30 |  | SIT |  | 6.1 | Complete |  | COMPLETE |  |  |  |  |  |  |  |  |
| 1313 | 1.4.1.4.8.6.5 | LDP Review - Config doc |  | 1d? | 2024-09-30 A | 2024-09-30 A |  | 100% |  | 2024-09-30 | 2024-09-30 | 0d |  |  |  | start no earlier than 2024-09-30 |  | SIT |  | 6.1 | Complete |  | COMPLETE |  |  |  |  |  |  |  |  |
| 1314 | 1.4.1.4.8.6.6 | SRO Review - Config doc |  | 1d? | 2024-09-30 A | 2024-09-30 A |  | 100% |  | 2024-09-30 | 2024-09-30 | 0d |  |  |  | start no earlier than 2024-09-30 |  | SIT |  | 6.1 | Complete |  | COMPLETE |  |  |  |  |  |  |  |  |
| 1315 | 1.4.1.4.8.6.7 | SRO Sign-off of all changes |  | 1d? | 2024-10-03 A | 2024-10-03 A |  | 100% |  | 2024-10-03 | 2024-10-03 | 0d |  |  |  | start no earlier than 2024-10-03 |  | SIT |  | 6.1 | Complete |  | COMPLETE |  |  |  |  |  |  |  |  |
| 1316 | 1.4.1.4.8.7 | **Azure DevOps Changes - Final Implementation** |  | 1d? | 2024-10-03 A | 2024-10-03 A |  | 100% |  | 2024-10-03 | 2024-10-03 | 0d |  |  |  |  |  | SIT | -701.67 | 6.1 | Overdue Start | Heath Thomas |  |  |  |  |  |  |  |  |  |
| 1317 | 1.4.1.4.8.7.1 | Final task rollout |  | 1d? | 2024-10-03 A | 2024-10-03 A |  | 100% |  | 2024-10-03 | 2024-10-03 | 0d |  |  |  | start no earlier than 2024-10-03 |  | SIT |  | 6.1 | Complete |  | COMPLETE |  |  |  |  |  |  |  |  |
| 1318 | 1.4.1.4.8.7.2 | ADO Training Drop-in Session ahead of Cycle 3 |  | 1d? | 2024-10-03 A | 2024-10-03 A |  | 100% |  | 2024-10-03 | 2024-10-03 | 0d |  |  |  | start no earlier than 2024-10-03 |  | SIT |  | 6.1 | Complete |  | COMPLETE |  |  |  |  |  |  |  |  |
| 1319 | 1.4.2 | **SIT Execution** |  | 804d? | 2022-10-31 A | 2025-11-27 |  | 16% | 679.27d? | 2022-10-31 | 2025-11-27 | 390d | 2023-10-30 | 2025-04-25 | 540d |  | -0 | SIT |  | 5.0 |  | N/A |  | N/A | N/A | Systems Integration Testing (SIT) |  |  |  |  |  |
| 1320 | 1.4.2.1 | System Integration Testing Start (M9) | milestone | 0d | 2023-10-30 A | 2023-10-30 A | 671FS+5d, 585 | 100% |  | 2023-10-30 | 2023-10-30 | 0d | 2023-10-30 | 2023-10-30 |  | must start on 2023-10-30 |  | SIT |  | 5.11 | Complete |  | COMPLETE | CPT | PMO | Systems Integration Testing (SIT) | MHHS-ART071 | T1-TE-1000 | PSG | T1 |  |
| 1321 | 1.4.2.2 | **SIT Component Integration Testing** |  | 96d | 2023-10-30 A | 2024-03-11 A |  | 100% |  | 2023-10-30 | 2024-03-11 | 95d | 2023-10-30 | 2024-03-08 |  |  |  | SIT |  | 5.0 |  | N/A |  | N/A | N/A | Systems Integration Testing (SIT) |  |  |  |  | D24A - Industry Integration Test Completion Report |
| 1322 | 1.4.2.2.1 | SIT Component Integration Testing Start | milestone | 0d | 2023-10-30 A | 2023-10-30 A | 1320 | 100% |  | 2023-10-30 | 2023-10-30 | 0d | 2023-10-30 | 2023-10-30 |  |  |  | SIT |  | 5.11 | Complete |  | COMPLETE | SI Test | PP | Systems Integration Testing (SIT) |  |  |  |  |  |
| 1323 | 1.4.2.2.2 | Component Integration Testing Interval 1 Start | milestone | 0d | 2023-10-30 A | 2023-10-30 A | 671SS+1d, 592, 596, 600, 114 | 100% |  | 2023-10-30 | 2023-10-30 | 0d | 2023-10-30 | 2023-10-30 |  |  |  | SIT |  | 5.11 | Complete |  | COMPLETE | SI Test | PP | Systems Integration Testing (SIT) | MHHS-ART071 | T3-TE-0060 | SITAG | T3 |  |
| 1324 | 1.4.2.2.3 | Component Integration Testing Interval 2 Start | milestone | 0d | 2023-11-13 A | 2023-11-13 A | 698SS+5d, 592, 600, 596, 114 | 100% |  | 2023-11-13 | 2023-11-13 | 0d | 2023-11-13 | 2023-11-13 |  |  |  | SIT |  | 5.12 | Complete |  | COMPLETE | SI Test | PP | Systems Integration Testing (SIT) |  | T3-TE-0061 | SITAG | T3 |  |
| 1325 | 1.4.2.2.4 | Component Integration Testing Interval 3 Start | milestone | 0d | 2023-11-27 A | 2023-11-27 A | 730SS+5d, 592, 596, 600, 114 | 100% |  | 2023-11-27 | 2023-11-27 | 0d | 2023-11-27 | 2023-11-27 |  |  |  | SIT |  | 5.0 | Complete |  | COMPLETE | SI Test | PP | Systems Integration Testing (SIT) |  | T3-TE-0062 | SITAG | T3 |  |
| 1326 | 1.4.2.2.5 | Component Integration Testing Interval 4 Start | milestone | 0d | 2023-12-11 A | 2023-12-11 A | 762SS+5d, 592, 596, 600, 114 | 100% |  | 2023-12-11 | 2023-12-11 | 0d | 2023-12-11 | 2023-12-11 |  |  |  | SIT |  | 5.0 | Complete |  | COMPLETE | SI Test | PP | Systems Integration Testing (SIT) |  | T3-TE-0063 | SITAG | T3 |  |
| 1327 | 1.4.2.2.6 | Component Integration Testing Interval 5 Start | milestone | 0d | 2024-01-15 A | 2024-01-15 A | 794SS+5d, 592, 596, 600, 114 | 100% |  | 2024-01-15 | 2024-01-15 | 0d | 2024-01-15 | 2024-01-15 |  |  |  | SIT |  | 5.0 | Complete |  | COMPLETE | SI Test | PP | Systems Integration Testing (SIT) |  | T3-TE-0064 |  | T3 |  |
| 1328 | 1.4.2.2.7 | Component Integration Testing Interval 6 Start | milestone | 0d | 2024-01-29 A | 2024-01-29 A | 592, 596, 600, 826, 114, 638 | 100% |  | 2024-01-29 | 2024-01-29 | 0d | 2024-01-29 | 2024-01-29 |  | must start on 2024-01-29 |  | SIT |  | 5.0 | Complete |  | COMPLETE | SI Test | PP | Systems Integration Testing (SIT) |  | T3-TE-0065 | SITAG | T3 |  |
| 1329 | 1.4.2.2.8 | SIT Component Integration Testing Execution |  | 85d | 2023-10-30 A | 2024-02-23 A | 1323SS | 100% |  | 2023-10-30 | 2024-02-23 | 85d | 2023-10-30 | 2024-02-23 |  | must start on 2023-10-30 |  | SIT |  | 5.0 | Complete |  | COMPLETE | SI Test | PP | Systems Integration Testing (SIT) |  |  |  |  | D24A - Industry Integration Test Completion Report |
| 1330 | 1.4.2.2.9 | SIT Component Integration Testing End (incl. confirmation that PPs have submitted their Test Completion Reports to Programme for assurance) | milestone | 0d | 2024-02-23 A | 2024-02-23 A | 1329FF | 100% |  | 2024-02-23 | 2024-02-23 | 0d | 2024-02-23 | 2024-02-23 |  |  |  | SIT |  | 5.19 | Complete |  | COMPLETE | SI Test | PP | Systems Integration Testing (SIT) | MHHS-ART074 | T3-TE-0032 | SITAG | T3 |  |
| 1331 | 1.4.2.2.10 | Assurance of PPs Test Completion Reports |  | 30d | 2024-01-22 A | 2024-03-01 A | 1330FF+5d | 100% |  | 2024-01-22 | 2024-03-01 | 30d | 2024-01-22 | 2024-03-01 |  |  |  | SIT |  | 5.19 | Complete |  | COMPLETE | SI Test | PP | Systems Integration Testing (SIT) |  |  |  |  |  |

| ID | WBS | Task | Type | Duration | Start | Finish | Predecessors | Complete | Remaining | Baseline start | Baseline finish | Baseline duration | Baseline 1 start | Baseline 1 finish | Total slack | Free slack | Baseline cost | Responsible | Involved | Text9 | Update Version | MHHS Resource Name | MHHS Programme Phase | Sched Status | RAG | Artefact ID | Milestone ID | Text29 | Tier | Text3 | Task Status |
| --- | --- | --- | --- | --- | --- | --- | --- | --- | --- | --- | --- | --- | --- | --- | --- | --- | --- | --- | --- | --- | --- | --- | --- | --- | --- | --- | --- | --- | --- | --- | --- |
| 1332 | 1.4.2.2.11 | **SIT CI Test Completion Report** |  | 18d | 2024-02-07 A | 2024-03-01 A |  | 100% |  | 2024-02-07 | 2024-03-01 | 18d | 2024-02-07 | 2024-03-01 |  |  |  | N/A | N/A | SIT | 5.0 | N/A | Systems Integration Testing (SIT) |  |  |  |  |  |  |  |  |
| 1333 | 1.4.2.2.11.1 | Develop document |  | 13d | 2024-02-07 A | 2024-02-23 A | 1330FF | 100% |  | 2024-02-07 | 2024-02-23 | 13d | 2024-02-07 | 2024-02-23 |  |  |  | SI Test |  | SIT | 5.19 |  | Systems Integration Testing (SIT) | Complete | COMPLETE |  |  |  |  |  |  |
| 1334 | 1.4.2.2.11.2 | Review & agree document |  | 5d | 2024-02-26 A | 2024-03-01 A | 1333, 1331FF | 100% |  | 2024-02-26 | 2024-03-01 | 5d | 2024-02-26 | 2024-03-01 |  |  |  | SI Test | PP,IPA | SIT | 5.19 |  | Systems Integration Testing (SIT) | Complete | COMPLETE |  |  |  |  |  |  |
| 1335 | 1.4.2.2.12 | SIT Component Integration Testing Test Completion Report Approved | milestone | 0d | 2024-03-11 A | 2024-03-11 A | 1334FS+6d | 100% |  | 2024-03-11 | 2024-03-11 | 0d | 2024-03-08 | 2024-03-08 |  |  |  | SI Test | PP | SIT | 5.18 |  | Systems Integration Testing (SIT) | Complete | COMPLETE | MHHS-ART074 | T2-TE-0600 | SITAG | T2 |  |  |
| 1336 | 1.4.2.3 | **SIT - Minimum Viable Cohort (MVC)** |  | 735d? | 2022-10-31 A | 2025-08-22 |  | 8% | 675.26d? | 2022-10-31 | 2025-08-22 | 240d | 2024-03-11 | 2025-02-07 | 609d |  | -0 | N/A | N/A | SIT | 5.0 | N/A | Systems Integration Testing (SIT) |  |  |  |  |  |  |  |  |
| 1337 | 1.4.2.3.1 | **SIT Functional Testing (MVC)** |  | 730d? | 2022-10-31 A | 2025-08-15 |  | 20% | 582.61d? | 2022-10-31 | 2025-08-15 | 225d | 2024-03-11 | 2025-01-17 | 614d |  |  | N/A | N/A | SIT | 5.0 | N/A | Systems Integration Testing (SIT) |  |  |  |  |  |  |  |  |
| 1338 | 1.4.2.3.1.1 | SIT Functional Testing Start | milestone | 0d | 2024-03-11 A | 2024-03-11 A | 1335, 967FS+5d, 833, 841, 842, 843, 850 | 100% |  | 2024-03-11 | 2024-03-11 | 0d | 2024-03-11 | 2024-03-11 |  |  |  | SI Test | PP | SIT | 6.1 |  | Systems Integration Testing (SIT) | Complete | COMPLETE | MHHS-ART073 | T3-TE-0034 | SITAG | T3 |  |  |
| 1339 | 1.4.2.3.1.2 | **SIT Functional Testing Execution (Minimum Viable Cohort)** |  | 730d? | 2022-10-31 A | 2025-08-15 |  | 20% | 582.61d? | 2022-10-31 | 2025-08-15 | 225d | 2024-03-11 | 2025-01-17 | 614d |  |  | N/A | N/A | SIT | 5.0 | N/A | Systems Integration Testing (SIT) |  |  |  |  |  |  | D24C - E2E Test Completion Report | M10 |
| 1340 | 1.4.2.3.1.2.1 | **Cycle 1 (Full Cycle)** |  | 70d | 2024-03-11 A | 2024-06-14 A |  | 100% |  | 2024-03-11 | 2024-06-14 | 90d | 2024-03-11 | 2024-07-12 |  |  |  | N/A | N/A | SIT | 5.0 | N/A | Systems Integration Testing (SIT) |  |  |  |  |  |  |  |  |
| 1341 | 1.4.2.3.1.2.1.1 | Test Execution |  | 55d | 2024-03-11 A | 2024-05-24 A | 1338SS-1d, 926 | 100% |  | 2024-03-11 | 2024-05-24 | 80d | 2024-03-11 | 2024-06-28 |  |  |  | PP | SI Test | SIT | 5.0 |  | Systems Integration Testing (SIT) | Complete | COMPLETE |  |  |  |  |  |  |
| 1342 | 1.4.2.3.1.2.1.2 | Defect resolution, assurance, review, data & environments maintenance |  | 15d | 2024-05-27 A | 2024-06-14 A | 1341 | 100% |  | 2024-05-27 | 2024-06-14 | 10d | 2024-07-01 | 2024-07-12 |  |  |  | SI Test | PP | SIT | 5.0 |  | Systems Integration Testing (SIT) | Complete | COMPLETE |  |  |  |  |  |  |
| 1343 | 1.4.2.3.1.2.2 | **Cycle 2 (Defect retests and targeted regression testing)** |  | 80d | 2024-06-17 A | 2024-10-04 |  | 41% | 47d | 2024-06-17 | 2024-10-04 | 50d | 2024-07-15 | 2024-09-20 | 839d |  |  | N/A | N/A | SIT | 5.0 | N/A | Systems Integration Testing (SIT) |  |  |  |  |  |  |  |  |
| 1344 | 1.4.2.3.1.2.2.1 | Test Execution |  | 70d | 2024-06-17 A | 2024-09-20 | 1342, 931 | 47% | 37d | 2024-06-17 | 2024-09-20 | 40d | 2024-07-15 | 2024-09-06 | 190d | 0d |  | PP | SI Test | SIT | 5.0 | Roger Robar | Systems Integration Testing (SIT) | Overdue | RED |  |  |  |  |  |  |
| 1345 | 1.4.2.3.1.2.2.2 | Defect resolution, assurance, review, data & environments maintenance |  | 10d | 2024-09-23 | 2024-10-04 | 1344 |  |  | 2024-09-23 | 2024-10-04 | 10d | 2024-09-09 | 2024-09-20 | 839d | 0d |  | SI Test | PP | SIT | 5.0 | Roger Robar | Systems Integration Testing (SIT) | Overdue Start | RED |  |  |  |  |  | -37.67 |
| 1346 | 1.4.2.3.1.2.3 | **SIT Functional Testing back-up progress risk-assessment** |  | 0d | 2022-10-31 | 2022-10-31 |  |  |  | 2022-10-31 | 2022-10-31 | 20d | 2024-09-23 | 2024-10-18 | 1344d |  |  | N/A | N/A | SIT | 5.31 | N/A | Systems Integration Testing (SIT) |  |  |  |  |  |  |  |  |
| 1347 | 1.4.2.3.1.2.3.1 | Back-up risk-assessment of SIT Functional progress to assess whether Qualification Execution can start early | inactive | 15d | 2024-10-07 | 2024-10-25 | 1345 |  |  | 2024-10-07 | 2024-10-25 | 15d | 2024-09-23 | 2024-10-11 | 819d | 0d |  | SI Test | Code Bodies,PP,IPA | SIT | 5.31 | Nicola Farley | Systems Integration Testing (SIT) |  | GREEN |  |  |  |  |  | -23.67 |
| 1348 | 1.4.2.3.1.2.3.2 | Back-up SITAG decision on early Qualification Testing Execution start | milestone, inactive | 0d | 2024-11-01 | 2024-11-01 | 1347FS+5d |  |  | 2024-11-01 | 2024-11-01 | 0d | 2024-10-18 | 2024-10-18 | 819d |  |  | SI Test | Code Bodies,PP,IPA | SIT | 5.31 | Nicola Farley | Systems Integration Testing (SIT) |  | GREEN |  | T3-TE-0041 | QAG | T3 |  | 1.71 |
| 1349 | 1.4.2.3.1.2.4 | **Cycle 3 (Defect retests and targeted regression testing)** |  | 105d? | 2024-10-21 A | 2025-03-14 |  | 2% | 102.83d? | 2024-10-21 | 2025-03-14 | 30d | 2024-09-23 | 2024-11-01 |  |  |  | N/A | N/A | SIT | 5.0 | N/A | Systems Integration Testing (SIT) |  |  |  |  |  |  |  |  |
| 1350 | 1.4.2.3.1.2.4.1 | Sprint 5 |  | 10d? | 2024-10-21 A | 2024-11-01 | 140SS-1d | 30% | 7d? | 2024-10-21 | 2024-11-01 | 0d |  |  | 5d | 0d |  |  |  | SIT | 6.0 | Roger Robar |  | Green | GREEN |  |  |  |  |  |  |
| 1351 | 1.4.2.3.1.2.4.2 | Sprint 6 |  | 10d? | 2024-11-04 | 2024-11-15 | 1350 |  |  | 2024-11-04 | 2024-11-15 | 0d |  |  | 5d | 0d |  |  |  | SIT | 6.0 | Roger Robar |  | Green | GREEN |  |  |  |  |  | 4.33 |
| 1352 | 1.4.2.3.1.2.4.3 | Sprint 7 |  | 10d? | 2024-11-18 | 2024-11-29 | 1351 |  |  | 2024-11-18 | 2024-11-29 | 0d |  |  | 5d | 0d |  |  |  | SIT | 6.0 | Roger Robar |  | Green | GREEN |  |  |  |  |  | 18.33 |
| 1353 | 1.4.2.3.1.2.4.4 | Sprint 8 |  | 15d? | 2024-12-02 | 2024-12-20 | 1352 |  |  | 2024-12-02 | 2024-12-20 | 0d |  |  | 5d | 0d |  |  |  | SIT | 6.0 | Roger Robar |  | Green | GREEN |  |  |  |  |  | 32.33 |
| 1354 | 1.4.2.3.1.2.4.5 | Christmas downtime |  | 10d? | 2024-12-23 | 2025-01-03 | 1353 |  |  | 2024-12-23 | 2025-01-03 | 0d |  |  | 5d | 0d |  |  |  | SIT | 6.0 | Roger Robar |  | Green | GREEN |  |  |  |  |  | 53.33 |
| 1355 | 1.4.2.3.1.2.4.6 | Sprint 9 |  | 10d? | 2025-01-06 | 2025-01-17 | 1354 |  |  | 2025-01-06 | 2025-01-17 | 0d |  |  | 5d | 0d |  |  |  | SIT | 6.0 | Roger Robar |  | Green | GREEN |  |  |  |  |  | 67.33 |
| 1356 | 1.4.2.3.1.2.4.7 | Sprint 10 |  | 10d? | 2025-01-20 | 2025-01-31 | 1355 |  |  | 2025-01-20 | 2025-01-31 | 0d |  |  | 5d | 0d |  |  |  | SIT | 6.0 | Roger Robar |  | Green | GREEN |  |  |  |  |  | 81.33 |
| 1357 | 1.4.2.3.1.2.4.8 | Sprint 11 |  | 10d? | 2025-02-03 | 2025-02-14 | 1356 |  |  | 2025-02-03 | 2025-02-14 | 0d |  |  | 5d | 0d |  |  |  | SIT | 6.0 | Roger Robar |  | Green | GREEN |  |  |  |  |  | 95.33 |
| 1358 | 1.4.2.3.1.2.4.9 | Sprint 12 |  | 10d? | 2025-02-17 | 2025-02-28 | 1357 |  |  | 2025-02-17 | 2025-02-28 | 0d |  |  | 5d | 0d |  |  |  | SIT | 6.0 | Roger Robar |  | Green | GREEN |  |  |  |  |  | 109.33 |
| 1359 | 1.4.2.3.1.2.4.10 | Sprint 13 (RTTM Gap Analysis + CR056) |  | 10d? | 2025-03-03 | 2025-03-14 | 1358 |  |  | 2025-03-03 | 2025-03-14 | 0d |  |  | 5d | 0d |  |  |  | SIT | 6.0 | Roger Robar |  | Green | GREEN |  |  |  |  |  | 123.33 |
| 1360 | 1.4.2.3.1.2.4.11 | Sprint 14 (RTTM Gap Analysis + CR056) |  | 10d? | 2025-03-17 | 2025-03-28 | 1359 |  |  | 2025-03-17 | 2025-03-28 | 0d |  |  | 5d | 0d |  |  |  | SIT | 6.1 |  |  | Green | GREEN |  |  |  |  |  | 137.33 |
| 1361 | 1.4.2.3.1.2.4.12 | Sprint 15 (Contingency 1) |  | 10d? | 2025-03-31 | 2025-04-11 | 1360 |  |  | 2025-03-31 | 2025-04-11 | 0d |  |  | 5d | 0d |  |  |  | SIT | 6.1 |  |  | Green | GREEN |  |  |  |  |  | 151.33 |
| 1362 | 1.4.2.3.1.2.4.13 | Sprint 16 (Contingency 2) |  | 10d? | 2025-04-14 | 2025-04-25 | 1361 |  |  | 2025-04-14 | 2025-04-25 | 0d |  |  | 5d | 0d |  |  |  | SIT | 6.1 |  |  | Green | GREEN |  |  |  |  |  | 165.33 |
| 1363 | 1.4.2.3.1.2.4.14 | Defect resolution, assurance, review, data & environments maintenance |  | 10d | 2024-10-21 | 2024-11-01 |  |  |  | 2024-10-21 | 2024-11-01 | 10d | 2024-10-21 | 2024-11-01 | 819d |  |  | SI Test | PP | SIT | 6.1 | Roger Robar | Systems Integration Testing (SIT) | Overdue Start | GREEN |  |  |  |  |  | -9.67 |

Notes:
- 1347: Action: 5/12 - LC said change name from his to nicola and check dates based on new start date for non sit ldso testing
- 1348: 15/8/24: Milestone to be removed as no longer applicable / Guidance: 13/8/24: To be removed because SIT has not made sufficient progress to allow early quaifation test start. 22/8/24: Approved at QAG on 22/8/24 to be removed

| ID | WBS | Task | Type | Duration | Start | Finish | Predecessors | Complete | Remaining | Baseline start | Baseline finish | Baseline duration | Baseline 1 start | Baseline 1 finish | Total slack | Free slack | Constraint | Baseline cost | Text9 | Task Status | Update Version | Sched Status | RAG | Responsible | Involved | MHHS Programme Phase | MHHS Resource Name | Artefact ID | Milestone ID | Text29 | Tier |
| --- | --- | --- | --- | --- | --- | --- | --- | --- | --- | --- | --- | --- | --- | --- | --- | --- | --- | --- | --- | --- | --- | --- | --- | --- | --- | --- | --- | --- | --- | --- | --- |
| 1364 | 1.4.2.3.1.2.5 | **SIT Functional Settlement Testing** |  | 230d? | 2024-06-17 | 2025-05-02 |  |  |  | 2024-06-17 | 2025-05-02 | 0d |  |  |  |  |  |  | SIT | -685.67 | 6.0 | Overdue Start | RED |  |  |  |  |  |  |  |  |
| 1365 | 1.4.2.3.1.2.5.1 | Settlement Testing Cycle 1 |  | 70d | 2024-06-17 | 2024-09-20 |  |  |  | 2024-06-17 | 2024-09-20 | 0d |  |  | 849d |  | start no earlier than 2024-06-17 |  | SIT | -135.67 | 6.0 | Overdue Start | RED |  |  |  |  |  |  |  |  |
| 1366 | 1.4.2.3.1.2.5.2 | Settlement Testing Cycle 2 |  | 55d? | 2024-10-07 | 2024-12-20 | 1239 |  |  | 2024-10-07 | 2024-12-20 | 0d |  |  | 60d | 0d |  |  | SIT | -23.67 | 6.0 | Overdue Start | GREEN |  |  |  |  |  |  |  |  |
| 1367 | 1.4.2.3.1.2.5.3 | Settlement Testing Cycle 3 (CoS Settlement Testing) |  | 20d? | 2025-05-19 | 2025-06-13 | 957, 1266 |  |  | 2025-05-19 | 2025-06-13 | 0d |  |  | 5d | 0d |  |  | SIT | 200.33 | 6.0 | Green | GREEN |  |  |  |  |  |  |  |  |
| 1368 | 1.4.2.3.1.2.6 | **SIT Functional MVC Regression Testing (code freeze)** |  | 40d? | 2025-06-16 | 2025-08-08 |  |  |  | 2025-06-16 | 2025-08-08 | 45d | 2024-11-04 | 2025-01-03 | 5d |  |  |  | SIT | 84.33 | 5.0 | Red | RED | PP | SI Test | Systems Integration Testing (SIT) |  |  |  |  |  |
| 1369 | 1.4.2.3.1.2.6.1 | Regression Sprint 1 |  | 10d? | 2025-06-16 | 2025-06-27 | 1367, 1262 |  |  | 2025-06-16 | 2025-06-27 | 0d |  |  | 5d | 0d |  |  | SIT | 228.33 | 6.0 | Green | GREEN |  |  |  | Roger Robar |  |  |  |  |
| 1370 | 1.4.2.3.1.2.6.2 | Regression Sprint 2 |  | 10d | 2025-06-30 | 2025-07-11 | 1369 |  |  | 2025-06-30 | 2025-07-11 | 0d |  |  | 5d | 0d |  |  | SIT | 242.33 | 6.0 | Green | GREEN |  |  |  | Roger Robar |  |  |  |  |
| 1371 | 1.4.2.3.1.2.6.3 | Regression Sprint 3 |  | 15d | 2025-07-14 | 2025-08-01 | 1370 |  |  | 2025-07-14 | 2025-08-01 | 0d |  |  | 5d | 0d |  |  | SIT | 256.33 | 6.0 | Green | GREEN |  |  |  | Roger Robar |  |  |  |  |
| 1372 | 1.4.2.3.1.2.6.4 | SIT Functional Testing End (Minimum Viable Cohort) (incl. confirmation that PPs have submitted their Test Completion Reports to Programme for assurance) | milestone | 0d | 2025-08-01 | 2025-08-01 | 1371 |  |  | 2025-08-01 | 2025-08-01 | 0d | 2025-01-03 | 2025-01-03 | 5d | 0d | start no earlier than 2025-03-14 |  | SIT | 274.71 | 6.1 | Green | AMBER | SI Test | PP | Systems Integration Testing (SIT) | Roger Robar | MHHS-ART072 | T3-TE-0046 | SITAG | T3 |
| 1373 | 1.4.2.3.1.2.6.5 | Assurance of PPs Test Completion Reports |  | 30d | 2025-06-30 | 2025-08-08 | 1372FF+5d |  |  | 2025-06-30 | 2025-08-08 | 30d | 2024-12-02 | 2025-01-10 | 5d | 0d |  |  | SIT | 242.33 | 6.1 | Green | GREEN | SI Test | PP | Systems Integration Testing (SIT) | Roger Robar |  |  |  |  |
| 1374 | 1.4.2.3.1.2.7 | **SIT Functional Test Completion Report (Minimum Viable Cohort)** |  | 25d | 2025-07-14 | 2025-08-15 |  |  |  | 2025-07-14 | 2025-08-15 | 20d | 2024-12-16 | 2025-01-10 | 5d |  |  |  | SIT |  | 6.1 |  |  | N/A | N/A | Systems Integration Testing (SIT) | N/A |  |  |  |  |
| 1375 | 1.4.2.3.1.2.7.1 | Develop document |  | 15d | 2025-07-14 | 2025-08-01 | 1372FF |  |  | 2025-07-14 | 2025-08-01 | 15d | 2024-12-16 | 2025-01-03 | 5d | 0d |  |  | SIT | 256.33 | 6.1 | Green | GREEN | SI Test |  | Systems Integration Testing (SIT) | Roger Robar |  |  |  |  |
| 1376 | 1.4.2.3.1.2.7.2 | Review & agree document |  | 5d | 2025-08-04 | 2025-08-08 | 1375, 1373FF |  |  | 2025-08-04 | 2025-08-08 | 5d | 2025-01-06 | 2025-01-10 | 5d | 0d |  |  | SIT | 277.33 | 6.1 | Green | GREEN | SI Test | PP,IPA | Systems Integration Testing (SIT) | Roger Robar |  |  |  |  |
| 1377 | 1.4.2.3.1.2.7.3 | SIT Functional Testing Test Completion Report (Minimum Viable Cohort) Approved | milestone | 0d | 2025-08-15 | 2025-08-15 | 1376FF+5d |  |  | 2025-08-15 | 2025-08-15 | 0d | 2025-01-17 | 2025-01-17 | 5d | 0d |  |  | SIT | 288.71 | 6.1 | Green | AMBER | SI Test | PP | Systems Integration Testing (SIT) | Roger Robar | MHHS-ART072 | T2-TE-0850 | SITAG | T2 |
| 1378 | 1.4.2.3.2 | **Helix E2E Settlement Testing** |  | 65d | 2025-01-06 | 2025-04-04 |  |  |  | 2025-01-06 | 2025-04-04 | 0d |  |  | 709d |  |  |  | SIT | -689.67 |  | Overdue Start | RED |  |  |  | Helix |  |  |  |  |
| 1379 | 1.4.2.3.2.1 | Helix E2E Settlement Testing Execution |  | 65d | 2025-01-06 | 2025-04-04 | 1366FS+10d |  |  | 2025-01-06 | 2025-04-04 | 0d |  |  | 709d | 0d |  |  | SIT | 67.33 | 6.0 | Green | GREEN |  |  |  | Helix |  |  |  |  |
| 1380 | 1.4.2.3.2.2 | Helix E2E Settlement Testing Execution Complete | milestone | 0d | 2025-04-04 | 2025-04-04 | 1379 |  |  | 2025-04-04 | 2025-04-04 | 0d |  |  | 709d |  |  |  | SIT | 155.71 | 6.0 | Green | GREEN |  |  |  | Helix |  |  |  |  |
| 1381 | 1.4.2.3.2.3 | MHHSP Helix E2E Testing Assurance |  | 65d | 2025-01-06 | 2025-04-04 | 1366FS+10d |  |  | 2025-01-06 | 2025-04-04 | 0d |  |  | 709d | 0d |  |  | SIT | 67.33 | 6.0 | Green | GREEN |  |  |  | Helix |  |  |  |  |
| 1382 | 1.4.2.3.2.4 | MHHSP Helix E2E Testing Assurance Complete | milestone | 0d | 2025-04-04 | 2025-04-04 | 1381 |  |  | 2025-04-04 | 2025-04-04 | 0d |  |  | 709d |  |  |  | SIT | 155.71 | 6.0 | Green | GREEN |  |  |  | Helix |  |  |  |  |
| 1383 | 1.4.2.3.3 | **SIT Migration Testing (MVC)** |  | 380d? | 2024-03-11 A | 2025-08-22 |  | 1% | 377.04d? | 2024-03-11 | 2025-08-22 | 155d | 2024-06-10 | 2024-10-18 | 609d |  |  | -0 | SIT |  | 6.0 | Overdue | GREEN | N/A | N/A | Systems Integration Testing (SIT) | N/A |  |  |  |  |
| 1384 | 1.4.2.3.3.1 | SIT Migration Testing Start | milestone | 0d? | 2024-03-11 | 2024-03-11 |  |  |  | 2024-03-11 | 2024-03-11 | 0d |  |  | 989d |  | start no earlier than 2024-03-11 |  | SIT | -233.67 | 6.0 | Overdue Start | RED |  |  |  |  |  |  |  |  |
| 1385 | 1.4.2.3.3.2 | **SIT Migration Testing Execution (Minimum Viable Cohort)** |  | 380d? | 2024-03-11 A | 2025-08-22 |  | 1% | 377.04d? | 2024-03-11 | 2025-08-22 | 0d |  |  | 609d |  |  |  | SIT | -685.67 | 6.0 | Overdue Start | RED |  |  |  |  |  |  |  |  |
| 1386 | 1.4.2.3.3.2.1 | **Cycle 1 (Full Cycle)** |  | 70d? | 2024-03-11 | 2024-06-14 |  |  |  | 2024-03-11 | 2024-06-14 | 0d |  |  |  |  |  |  | SIT | -685.67 | 6.0 | Overdue Start | RED |  |  |  |  |  |  |  |  |
| 1387 | 1.4.2.3.3.2.1.1 | Test Execution |  | 55d? | 2024-03-11 | 2024-05-24 |  |  |  |  |  |  |  |  | 934d |  | start no earlier than 2024-03-11 |  | SIT | -233.67 | 6.0 | Overdue Start | RED |  |  |  |  |  |  |  |  |
| 1388 | 1.4.2.3.3.2.1.2 | Defect resolution, assurance, review, data& environments maintenance |  | 15d? | 2024-05-27 | 2024-06-14 |  |  |  |  |  |  |  |  | 819d | 0d | finish no earlier than 2024-06-14 |  | SIT | -156.67 | 6.0 | Overdue Start | RED |  |  |  |  |  |  |  |  |

Notes:
- 1372: 16/09/24 - Date pushed back to 14/03/25, in line with recalibration exercise.
- 1377: 6/8/24: Date at risk due to lower than expected test velocity. Completion of Functional could be delayed. Programme-wide scenario re-planning underway

| ID | WBS | Task | Type | Duration | Start | Finish | Predecessors | Complete | Remaining | Baseline start | Baseline finish | Baseline duration | Total slack | Free slack | Constraint | Text9 | Task Status | Update Version | Sched Status | RAG | MHHS Resource Name |
| --- | --- | --- | --- | --- | --- | --- | --- | --- | --- | --- | --- | --- | --- | --- | --- | --- | --- | --- | --- | --- | --- |
| 1389 | 1.4.2.3.3.2.2 | **Cycle 2 (Defect retests and targeted regression testing)** |  | 80d? | 2024-03-11 | 2024-06-28 |  |  |  | 2024-03-11 | 2024-06-28 | 0d |  |  |  | SIT | -685.67 | 6.0 | Overdue Start | RED |  |
| 1390 | 1.4.2.3.3.2.2.1 | Test Execution |  | 70d? | 2024-06-17 | 2024-09-20 | 1388 |  |  |  |  |  | 819d | 0d | start no earlier than 2024-06-17 | SIT | -135.67 | 6.0 | Overdue Start | RED |  |
| 1391 | 1.4.2.3.3.2.2.2 | Defect resolution, assurance, review, data & environments maintenance |  | 10d? | 2024-09-23 | 2024-10-04 | 1390 |  |  |  |  |  | 819d | 0d | finish no earlier than 2024-10-04 | SIT | -37.67 | 6.0 | Overdue Start | RED |  |
| 1392 | 1.4.2.3.3.2.3 | **SIT Functional Testing back-up progress risk-assessment** |  | 70d? | 2024-06-17 | 2024-09-20 |  |  |  | 2024-06-17 | 2024-09-20 | 0d |  |  |  | SIT | -685.67 | 6.0 | Overdue Start | RED |  |
| 1393 | 1.4.2.3.3.2.3.1 | Back-up risk-assessment of SIT Migration progress to assess whether Qualification Execution can start early |  | 15d? | 2024-10-07 | 2024-10-25 | 1391 |  |  | 2024-10-07 | 2024-10-25 | 0d | 819d | 0d | finish no earlier than 2024-10-04 | SIT | -23.67 | 6.0 | Overdue Start | GREEN |  |
| 1394 | 1.4.2.3.3.2.3.2 | Back-up SITAG decision on early Qualification Testing Execution start | milestone | 0d? | 2024-11-01 | 2024-11-01 | 1393FS+5d |  |  | 2024-11-01 | 2024-11-01 | 0d | 819d |  |  | SIT | 1.71 | 6.0 | Green | GREEN |  |
| 1395 | 1.4.2.3.3.2.4 | **Cycle 3 (Defect retests and targeted regression testing)** |  | 135d? | 2024-10-21 A | 2025-04-25 |  | 2% | 132d? | 2024-10-21 | 2025-04-25 | 0d | 5d |  |  | SIT | -685.67 | 6.0 | Overdue Start | RED | Roger Robar |
| 1396 | 1.4.2.3.3.2.4.1 | Sprint 5 |  | 10d | 2024-10-21 A | 2024-11-01 | 140FS-1d | 30% | 7d | 2024-10-21 | 2024-11-01 | 0d | 5d | 0d | start no earlier than 2024-10-21 | SIT |  | 6.0 | Green | GREEN |  |
| 1397 | 1.4.2.3.3.2.4.2 | Sprint 6 |  | 10d | 2024-11-04 | 2024-11-15 | 1396 |  |  | 2024-11-04 | 2024-11-15 | 0d | 5d | 0d | start no earlier than 2024-11-04 | SIT | 4.33 | 6.0 | Green | GREEN |  |
| 1398 | 1.4.2.3.3.2.4.3 | Sprint 7 |  | 10d | 2024-11-18 | 2024-11-29 | 1397 |  |  | 2024-11-18 | 2024-11-29 | 0d | 5d | 0d |  | SIT | 18.33 | 6.0 | Green | GREEN |  |
| 1399 | 1.4.2.3.3.2.4.4 | Sprint 8 |  | 15d | 2024-12-02 | 2024-12-20 | 1398 |  |  | 2024-12-02 | 2024-12-20 | 0d | 5d | 0d | finish no earlier than 2024-11-15 | SIT | 32.33 | 6.0 | Green | GREEN |  |
| 1400 | 1.4.2.3.3.2.4.5 | Christmas downtime |  | 10d | 2024-12-23 | 2025-01-03 | 1399 |  |  | 2024-12-23 | 2025-01-03 | 0d | 5d | 0d | finish no earlier than 2024-11-29 | SIT | 53.33 | 6.0 | Green | GREEN |  |
| 1401 | 1.4.2.3.3.2.4.6 | Sprint 9 |  | 10d | 2025-01-06 | 2025-01-17 | 1400 |  |  | 2025-01-06 | 2025-01-17 | 0d | 5d | 0d | finish no earlier than 2024-12-20 | SIT | 67.33 | 6.0 | Green | GREEN |  |
| 1402 | 1.4.2.3.3.2.4.7 | Sprint 10 |  | 10d | 2025-01-20 | 2025-01-31 | 1401 |  |  | 2025-01-20 | 2025-01-31 | 0d | 5d | 0d | finish no earlier than 2025-01-03 | SIT | 81.33 | 6.0 | Green | GREEN |  |
| 1403 | 1.4.2.3.3.2.4.8 | Sprint 11 |  | 10d | 2025-02-03 | 2025-02-14 | 1402 |  |  | 2025-02-03 | 2025-02-14 | 0d | 5d | 0d | finish no earlier than 2025-01-17 | SIT | 95.33 | 6.0 | Green | GREEN |  |
| 1404 | 1.4.2.3.3.2.4.9 | Sprint 12 |  | 10d | 2025-02-17 | 2025-02-28 | 1403 |  |  | 2025-02-17 | 2025-02-28 | 0d | 5d | 0d | finish no earlier than 2025-01-31 | SIT | 109.33 | 6.0 | Green | GREEN |  |
| 1405 | 1.4.2.3.3.2.4.10 | Sprint 13 |  | 10d | 2025-03-03 | 2025-03-14 | 1404 |  |  | 2025-03-03 | 2025-03-14 | 0d | 5d | 0d |  | SIT | 123.33 | 6.1 | Green | GREEN |  |
| 1406 | 1.4.2.3.3.2.4.11 | Sprint 14 (RTTM Gap Analysis + CR056) |  | 10d? | 2025-03-17 | 2025-03-28 | 1405 |  |  | 2025-03-17 | 2025-03-28 | 0d | 5d | 0d |  | SIT | 137.33 | 6.1 | Green | GREEN |  |
| 1407 | 1.4.2.3.3.2.4.12 | Sprint 15 (Contingency 1) |  | 10d? | 2025-03-31 | 2025-04-11 | 1406 |  |  | 2025-03-31 | 2025-04-11 | 0d | 5d | 0d |  | SIT | 151.33 | 6.1 | Green | GREEN |  |
| 1408 | 1.4.2.3.3.2.4.13 | Sprint 16 (Contingency 2) |  | 10d? | 2025-04-14 | 2025-04-25 | 1407 |  |  | 2025-04-14 | 2025-04-25 | 0d | 5d | 0d |  | SIT | 165.33 | 6.1 | Green | GREEN |  |
| 1409 | 1.4.2.3.3.2.5 | **SIT Migration MVC Regression Testing (code freeze)** |  | 35d? | 2025-06-16 | 2025-08-01 |  |  |  | 2025-06-16 | 2025-08-01 | 0d | 609d |  |  | SIT | -685.67 | 6.0 | Overdue Start | RED | Roger Robar |
| 1410 | 1.4.2.3.3.2.5.1 | Regression Sprint 1 |  | 10d? | 2025-06-16 | 2025-06-27 | 1367 |  |  | 2025-06-16 | 2025-06-27 | 0d | 609d | 0d |  | SIT | 228.33 | 6.0 | Green | GREEN |  |
| 1411 | 1.4.2.3.3.2.5.2 | Regression Sprint 2 |  | 10d? | 2025-06-30 | 2025-07-11 | 1410 |  |  | 2025-06-30 | 2025-07-11 | 0d | 609d | 0d |  | SIT | 242.33 | 6.0 | Green | GREEN |  |
| 1412 | 1.4.2.3.3.2.5.3 | Regression Sprint 3 |  | 15d? | 2025-07-14 | 2025-08-01 | 1411 |  |  | 2025-07-14 | 2025-08-01 | 0d | 609d | 0d |  | SIT | 256.33 | 6.0 | Green | GREEN |  |
| 1413 | 1.4.2.3.3.2.5.4 | SIT Migration Testing End (Minimum Viable Cohort) (incl. confirmation that PPs have submitted their Test Completion Reports to Programme for assurance) | milestone | 0d | 2025-08-01 | 2025-08-01 | 1412 |  |  | 2025-08-01 | 2025-08-01 | 0d | 609d | 0d | start no earlier than 2025-06-20 | SIT | 274.71 | 6.0 | Green | GREEN |  |

| ID | WBS | Task | Type | Duration | Start | Finish | Predecessors | Baseline start | Baseline finish | Baseline duration | Baseline 1 start | Baseline 1 finish | Total slack | Free slack | Constraint | Responsible | Involved | Artefact ID | Text9 | Update Version | Sched Status | MHHS Programme Phase | RAG | Milestone ID | Text29 | Tier | Text3 | Task Status | MHHS Resource Name | Guidance |
| --- | --- | --- | --- | --- | --- | --- | --- | --- | --- | --- | --- | --- | --- | --- | --- | --- | --- | --- | --- | --- | --- | --- | --- | --- | --- | --- | --- | --- | --- | --- |
| 1414 | 1.4.2.3.3.2.6 | **SIT Migration Test Completion Report (Minimum Viable Cohort)** |  | 25d | 2025-07-14 | 2025-08-15 | 1069, 974, 978, 985, 991, 997 | 2025-07-14 | 2025-08-15 | 0d | 2024-06-10 | 2024-06-10 | 609d |  |  | SI Test | PP | MHHS-ART076 | SIT | 6.1 | Complete | Systems Integration Testing (SIT) | COMPLETE | T3-TE-0038 | SITAG | T3 |  |  |  |  |
| 1415 | 1.4.2.3.3.2.6.1 | Develop document |  | 15d | 2025-07-14 | 2025-08-01 | 1413FF | 2025-07-14 | 2025-08-01 | 85d | 2024-06-10 | 2024-10-04 | 609d | 0d |  | SI Test | PP |  | SIT | 6.1 | Green | Systems Integration Testing (SIT) | GREEN |  |  |  | D24E - Migration Test Completion Report | 256.33 | Roger Robar |  |
| 1416 | 1.4.2.3.3.2.6.2 | Review & agree document |  | 5d | 2025-08-04 | 2025-08-08 | 1415 | 2025-08-04 | 2025-08-08 | 10d | 2024-10-21 | 2024-11-01 | 609d | 0d |  | SI Test | PP |  | SIT | 6.1 | Green | Systems Integration Testing (SIT) | GREEN |  |  |  |  | 277.33 | Roger Robar |  |
| 1417 | 1.4.2.3.3.2.6.3 | SIT Migration Testing Test Completion Report (Minimum Viable Cohort) Approved | milestone | 0d | 2025-08-15 | 2025-08-15 | 1416FS+5d | 2025-08-15 | 2025-08-15 | 45d |  |  | 609d | 0d |  |  |  |  | SIT | 6.1 | Green |  | GREEN | T2-TE-0800 |  |  |  | 288.71 |  |  |
| 1418 | 1.4.2.3.3.2.7 | SIT Migration Testing End (Minimum Viable Cohort) (incl. confirmation that PPs have submitted their Test Completion Reports to Programme for assurance) | milestone | 0d | 2025-08-15 | 2025-08-15 | 1415FF, 1417 | 2025-08-15 | 2025-08-15 | 0d | 2024-10-04 | 2024-10-04 | 609d | 0d | start no earlier than 2025-03-14 | SI Test | PP | MHHS-ART076 | SIT | 6.1 | Green | Systems Integration Testing (SIT) | AMBER | T3-TE-0043 | SITAG | T3 |  | 288.71 | Roger Robar |  |
| 1419 | 1.4.2.3.3.2.8 | Assurance of PPs Test Completion Reports |  | 30d | 2025-07-14 | 2025-08-22 | 1418FF+5d | 2025-07-14 | 2025-08-22 | 30d | 2024-09-02 | 2024-10-11 | 609d |  |  | SI Test | PP |  | SIT | 6.1 | Green | Systems Integration Testing (SIT) | GREEN |  |  |  |  | 256.33 | Roger Robar |  |
| 1420 | 1.4.2.3.4 | **SIT Non-Functional Testing (all SIT PPs)** |  | 104d? | 2025-01-13 | 2025-06-05 |  | 2025-01-13 | 2025-06-05 | 100d | 2024-09-02 | 2025-01-17 | 60d |  |  | N/A | N/A |  | SIT | 6.1 |  | Systems Integration Testing (SIT) |  |  |  |  |  |  | N/A |  |
| 1421 | 1.4.2.3.4.1 | Theme 1 (Helix and DIP Volume Testing) Start | milestone | 0d? | 2025-01-13 | 2025-01-13 | 1123 | 2025-01-13 | 2025-01-13 | 0d |  |  | 60d | 0d | start no earlier than 2025-01-13 |  |  |  | SIT | 6.0 | Green |  | GREEN | T3-TE-0124 |  |  |  | 74.33 |  |  |
| 1422 | 1.4.2.3.4.2 | Theme 1 (Helix and DIP Volume Testing) Execution |  | 15d? | 2025-01-13 | 2025-01-31 | 1421 | 2025-01-13 | 2025-01-31 | 0d |  |  | 60d | 0d | start no earlier than 2025-01-13 |  |  |  | SIT | 6.1 | Green |  | GREEN |  |  |  |  | 74.33 |  |  |
| 1423 | 1.4.2.3.4.3 | Theme 2 SIT Non-Functional Testing Start | milestone | 0d | 2025-03-14 | 2025-03-14 | 1139FS+5d, 1344FS+5d, 1076, 1080, 1087, 1093, 1099, 1125, 1129 | 2025-03-14 | 2025-03-14 | 0d | 2024-09-02 | 2024-09-02 | 70d | 0d |  | SI Test | PP | MHHS-ART079 | SIT | 6.1 | Green | Systems Integration Testing (SIT) | GREEN | T3-TE-0040 | SITAG | T3 |  | 134.71 | Roger Robar | 12/8/24: needs to be 7/10/24 |
| 1424 | 1.4.2.3.4.4 | Theme 2 SIT Non-Functional Testing Execution |  | 40d | 2025-03-17 | 2025-05-09 | 1423SS | 2025-03-17 | 2025-05-09 | 90d | 2024-09-02 | 2025-01-03 | 70d | 9d |  | SI Test | PP |  | SIT | 6.1 | Green | Systems Integration Testing (SIT) | GREEN |  |  |  | D24D - NF Test Completion Report | 137.33 | Roger Robar |  |
| 1425 | 1.4.2.3.4.5 | Theme 3 SIT Non-Functional Testing Start |  | 1d? | 2025-03-17 | 2025-03-17 | 1125, 1129 | 2025-03-17 | 2025-03-17 | 0d |  |  | 70d | 0d |  |  |  |  | SIT | 6.1 | Green |  | GREEN |  |  |  |  | 137.33 |  |  |
| 1426 | 1.4.2.3.4.6 | Theme 3 SIT Non-Functional Testing Execution |  | 40d? | 2025-03-17 | 2025-05-09 | 1425SS | 2025-03-17 | 2025-05-09 | 0d |  |  | 70d | 9d |  |  |  |  | SIT | 6.1 | Green |  | GREEN |  |  |  |  | 137.33 |  |  |
| 1427 | 1.4.2.3.4.7 | SIT Non-Functional Testing End (all SIT PPs) (incl. confirmation that PPs have submitted their Test Completion Reports to Programme for assurance) | milestone | 0d | 2025-05-23 | 2025-05-23 | 1424FF, 1426FF | 2025-05-23 | 2025-05-23 | 0d | 2025-01-03 | 2025-01-03 | 61d | 0d | start no earlier than 2025-05-23 | SI Test | PP | MHHS-ART079 | SIT | 6.1 | Green | Systems Integration Testing (SIT) | AMBER | T3-TE-0047 | SITAG | T3 |  | 204.33 | Roger Robar |  |
| 1428 | 1.4.2.3.4.8 | Assurance of PPs Test Completion Reports |  | 20d | 2025-05-02 | 2025-05-29 | 1427FF+5d | 2025-05-02 | 2025-05-29 | 30d | 2024-12-02 | 2025-01-10 | 61d | 0d |  | SI Test | PP |  | SIT | 6.1 | Green | Systems Integration Testing (SIT) | GREEN |  |  |  |  | 183.33 | Roger Robar |  |
| 1429 | 1.4.2.3.4.9 | **SIT Non-Functional Testing Test Completion Report (all SIT PPs)** |  | 20d | 2025-05-02 | 2025-05-29 |  | 2025-05-02 | 2025-05-29 | 20d | 2024-12-16 | 2025-01-10 | 61d |  |  | N/A | N/A |  | SIT | 6.1 |  | Systems Integration Testing (SIT) |  |  |  |  |  |  | N/A |  |
| 1430 | 1.4.2.3.4.9.1 | Develop document |  | 15d | 2025-05-02 | 2025-05-23 | 1427FF | 2025-05-02 | 2025-05-23 | 15d | 2024-12-16 | 2025-01-03 | 61d | 0d |  | SI Test |  |  | SIT | 6.1 | Green | Systems Integration Testing (SIT) | GREEN |  |  |  |  | 183.33 | Roger Robar |  |
| 1431 | 1.4.2.3.4.9.2 | Review & agree document |  | 5d | 2025-05-23 | 2025-05-29 | 1430, 1428FF | 2025-05-23 | 2025-05-29 | 5d | 2025-01-06 | 2025-01-10 | 61d | 0d |  | SI Test | PP,IPA |  | SIT | 6.1 | Green | Systems Integration Testing (SIT) | GREEN |  |  |  |  | 204.33 | Roger Robar |  |
| 1432 | 1.4.2.3.4.10 | SIT Non-Functional Testing Test Completion Report (all SIT PPs) Approved | milestone | 0d | 2025-06-05 | 2025-06-05 | 1431FF+5d | 2025-06-05 | 2025-06-05 | 0d | 2025-01-17 | 2025-01-17 | 61d | 56d |  | SI Test | PP | MHHS-ART079 | SIT | 6.1 | Green | Systems Integration Testing (SIT) | AMBER | T2-TE-0900 | SITAG | T2 |  | 217.71 | Roger Robar |  |
| 1433 | 1.4.2.3.5 | **SIT Operational Testing (all SIT PPs)** |  | 90d? | 2025-02-03 | 2025-06-06 |  | 2025-02-03 | 2025-06-06 | 90d | 2024-10-07 | 2025-02-07 | 60d |  |  | N/A | N/A |  | SIT | 5.0 |  | Systems Integration Testing (SIT) |  |  |  |  |  |  | N/A |  |
| 1434 | 1.4.2.3.5.1 | **Non-SIT B Testing** |  | 25d? | 2025-02-03 | 2025-03-07 |  | 2025-02-03 | 2025-03-07 | 0d |  |  | 115d |  |  |  |  |  | SIT |  | Overdue Start |  | RED |  |  |  |  | -686.67 |  |  |
| 1435 | 1.4.2.3.5.1.1 | SIT Operational Testing Start (Theme 3 - Batch 1 (Service Management)) | milestone | 0d? | 2025-02-03 | 2025-02-03 | 1226, 1165, 1190, 1191, 1206, 1225 | 2025-02-03 | 2025-02-03 | 0d |  |  | 115d | 0d | start no earlier than 2025-02-03 |  |  |  | SIT | 6.0 | Green |  | GREEN | T3-TE-0121 |  |  |  | 95.33 |  |  |
| 1436 | 1.4.2.3.5.1.2 | SIT Operational Testing Execution Window (Theme 3 - Batch 1 (Service Management)) |  | 25d? | 2025-02-03 | 2025-03-07 | 1435 | 2025-02-03 | 2025-03-07 | 0d |  |  | 115d | 55d | start no earlier than 2025-01-06 |  |  |  | SIT | 6.0 | Green |  | GREEN |  |  |  |  | 95.33 |  |  |
| 1437 | 1.4.2.3.5.2 | **SIT B Testing** |  | 70d? | 2025-02-07 | 2025-05-16 |  | 2025-02-07 | 2025-05-16 | 0d |  |  | 60d |  |  |  |  |  | SIT | 6.0 | Overdue Start |  | RED |  |  |  |  | -686.67 |  |  |
| 1438 | 1.4.2.3.5.2.1 | SIT Operational Testing Start (SIT B) | milestone | 0d | 2025-02-07 | 2025-02-07 | 1247FS+8d, 1146, 1150, 1157, 1163, 1226, 1126, 1127 | 2025-02-07 | 2025-02-07 | 0d | 2024-10-07 | 2024-10-07 | 60d | 0d |  | SI Test | PP | MHHS-ART073 MHHS-ART143 | SIT | 6.0 | Green | Systems Integration Testing (SIT) | AMBER | T3-TE-0042 | SITAG | T3 |  | 99.71 | Roger Robar |  |
| 1439 | 1.4.2.3.5.2.2 | SIT Operational Testing Execution Theme 3 Batch 2 |  | 25d? | 2025-02-10 | 2025-03-14 | 1438, 1215 | 2025-02-10 | 2025-03-14 | 0d |  |  | 60d | 0d |  |  |  |  | SIT | 6.0 | Green |  | GREEN |  |  |  |  | 102.33 |  |  |
| 1440 | 1.4.2.3.5.2.3 | SIT Operational Testing Execution Theme 1 |  | 25d? | 2025-03-17 | 2025-04-18 | 1439 | 2025-03-17 | 2025-04-18 | 0d |  |  | 60d | 0d |  |  |  |  | SIT | 6.0 | Green |  | GREEN |  |  |  |  | 137.33 |  |  |
| 1441 | 1.4.2.3.5.2.4 | SIT Operational Testing Execution Theme 2 |  | 20d? | 2025-04-21 | 2025-05-16 | 1440 | 2025-04-21 | 2025-05-16 | 0d |  |  | 60d | 0d |  |  |  |  | SIT | 6.0 | Green |  | GREEN |  |  |  |  | 172.33 |  |  |
| 1442 | 1.4.2.3.5.3 | SIT Operational Testing End (all SIT PPs) (incl. confirmation that PPs have submitted their Test Completion Reports to Programme for assurance) | milestone | 0d | 2025-05-23 | 2025-05-23 | 1441FS+5d, 1436 | 2025-05-23 | 2025-05-23 | 0d | 2025-01-24 | 2025-01-24 | 60d | 0d |  | SI Test | PP | MHHS-ART081 | SIT | 6.0 | Green | Systems Integration Testing (SIT) | AMBER | T3-TE-0050 | SITAG | T3 |  | 204.71 | Roger Robar |  |
| 1443 | 1.4.2.3.5.4 | Assurance of PPs Test Completion Reports |  | 30d | 2025-04-21 | 2025-05-30 | 1442FF+5d | 2025-04-21 | 2025-05-30 | 30d | 2024-12-23 | 2025-01-31 | 60d | 0d |  | SI Test | PP |  | SIT | 6.0 | Green | Systems Integration Testing (SIT) | GREEN |  |  |  |  | 172.33 | Roger Robar |  |

Notes:
- 1418: 16/09/24 - Date pushed back to 14/03/25, in line with recalibration exercise.
- 1423: Date missed due to lower than expected SIT functional test velocity. Forecast date updated and will be baselined once CR55 is approved.
- 1427: 16/09/24 - Date pushed back to 23/05/25, in line with recalibration exercise.
- 1432: 6/8/24: Date at risk due to lower than expected test velocity. Start of SIT-Non Functional (MVC) could be delayed. Programme-wide scenario re-planning underway
- 1435: 17/09/23 - Added new milestone
- 1438: Team has a dependency on Helix documentation that has been submitted late, which has impacted the approval of Theme 3 test scripts and test design. ~Date expected to move to 07/11/24.
- 1442: 16/09/24 - Date pushed back to 23/05/25, in line with recalibration exercise.

| ID | WBS | Task | Type | Duration | Start | Finish | Predecessors | Complete | Remaining | Baseline start | Baseline finish | Baseline duration | Baseline 1 start | Baseline 1 finish | Total slack | Free slack | Baseline cost | Responsible | Involved | Text9 | Update Version | MHHS Resource Name | MHHS Programme Phase | Task Status | Sched Status | RAG | Artefact ID | Milestone ID | Text29 | Tier | Text3 |
| --- | --- | --- | --- | --- | --- | --- | --- | --- | --- | --- | --- | --- | --- | --- | --- | --- | --- | --- | --- | --- | --- | --- | --- | --- | --- | --- | --- | --- | --- | --- | --- |
| 1444 | 1.4.2.3.5.5 | **SIT Operational Testing Test Completion Report (all SIT PPs)** |  | 20d | 2025-05-05 | 2025-05-30 |  |  |  | 2025-05-05 | 2025-05-30 | 20d | 2025-01-06 | 2025-01-31 | 60d |  |  | N/A | N/A | SIT | 6.0 | N/A | Systems Integration Testing (SIT) |  |  |  |  |  |  |  |  |
| 1445 | 1.4.2.3.5.5.1 | Develop document |  | 15d | 2025-05-05 | 2025-05-23 | 1442FF |  |  | 2025-05-05 | 2025-05-23 | 15d | 2025-01-06 | 2025-01-24 | 60d | 0d |  | SI Test |  | SIT | 6.0 | Roger Robar | Systems Integration Testing (SIT) | 186.33 | Green | GREEN |  |  |  |  |  |
| 1446 | 1.4.2.3.5.5.2 | Review & agree document |  | 5d | 2025-05-26 | 2025-05-30 | 1445, 1443FF |  |  | 2025-05-26 | 2025-05-30 | 5d | 2025-01-27 | 2025-01-31 | 60d | 0d |  | SI Test | PP,IPA | SIT | 6.0 | Roger Robar | Systems Integration Testing (SIT) | 207.33 | Green | GREEN |  |  |  |  |  |
| 1447 | 1.4.2.3.5.6 | SIT Operational Testing Test Completion Report (all SIT PPs) Approved | milestone | 0d | 2025-06-06 | 2025-06-06 | 1446FF+5d |  |  | 2025-06-06 | 2025-06-06 | 0d | 2025-02-07 | 2025-02-07 | 60d | 55d |  | SI Test | PP | SIT | 6.0 | Roger Robar | Systems Integration Testing (SIT) | 218.71 | Green | AMBER | MHHS-ART081 | T2-TE-0950 | SITAG | T2 |  |
| 1448 | 1.4.2.3.6 | **SIT MVC Test Exit Report** |  | 20d | 2025-07-14 | 2025-08-08 |  |  |  | 2025-07-14 | 2025-08-08 | 20d | 2025-01-06 | 2025-01-31 | 619d |  |  | N/A | N/A | SIT | 6.0 | N/A | Systems Integration Testing (SIT) |  |  |  |  |  |  |  |  |
| 1449 | 1.4.2.3.6.1 | Develop document |  | 15d | 2025-07-14 | 2025-08-01 | 1375FF |  |  | 2025-07-14 | 2025-08-01 | 15d | 2025-01-06 | 2025-01-24 | 619d | 0d |  | SI Test |  | SIT | 6.0 | Roger Robar | Systems Integration Testing (SIT) | 256.33 | Green | GREEN |  |  |  |  |  |
| 1450 | 1.4.2.3.6.2 | Review & agree document |  | 5d | 2025-08-04 | 2025-08-08 | 1449 |  |  | 2025-08-04 | 2025-08-08 | 5d | 2025-01-27 | 2025-01-31 | 619d |  |  | SI Test | PP,IPA | SIT | 6.0 | Roger Robar | Systems Integration Testing (SIT) | 277.33 | Green | GREEN |  |  |  |  |  |
| 1451 | 1.4.2.3.7 | SIT Minimum Viable Cohort Complete (SIT Minimum Viable Cohort Test Exit Report Approved) | milestone | 0d | 2025-08-22 | 2025-08-22 | 1335, 1377FS+5d, 1432, 1447 |  |  | 2025-08-22 | 2025-08-22 | 0d | 2025-02-07 | 2025-02-07 | 5d | 0d |  | CPT | PP,IPA | SIT | 6.0 | Roger Robar | Systems Integration Testing (SIT) | 295.71 | Green | AMBER | MHHS-ART081 | T1-TE-2000 | PSG | T1 |  |
| 1452 | 1.4.2.4 | **SIT (non-MVC)** |  | 119d? | 2025-06-16 A | 2025-11-27 |  | 10% | 106.64d? | 2025-05-05 | 2025-11-27 | 295d | 2024-03-11 | 2025-04-25 | 25d |  | -0 | N/A | N/A | SIT | 6.0 | N/A | Systems Integration Testing (SIT) | M10,M11 |  |  |  |  |  |  | D24D - NF Test Completion Report |
| 1453 | 1.4.2.4.1 | **SIT Functional Testing (non-MVC)** |  | 110d? | 2025-06-16 | 2025-11-14 |  |  |  | 2025-06-16 | 2025-11-14 | 295d | 2024-03-11 | 2025-04-25 | 25d |  |  | N/A | N/A | SIT | 6.0 | N/A | Systems Integration Testing (SIT) |  |  |  |  |  |  |  |  |
| 1454 | 1.4.2.4.1.1 | **SIT Functional Testing Execution (non-MVC)** |  | 95d? | 2025-06-16 | 2025-10-24 |  |  |  | 2025-06-16 | 2025-10-24 | 280d | 2024-03-11 | 2025-04-04 | 25d |  |  | N/A | N/A | SIT | 6.0 | N/A | Systems Integration Testing (SIT) | M10 |  |  |  |  |  |  | D24C - E2E Test Completion Report |
| 1455 | 1.4.2.4.1.1.1 | Test Execution (Cycle 3 Completion and Regression Testing) |  | 95d? | 2025-06-16 | 2025-10-24 | 1367 |  |  | 2025-06-16 | 2025-10-24 | 0d |  |  | 25d | 0d |  |  |  | SIT | 6.0 |  |  | 228.33 | Green | GREEN |  |  |  |  |  |
| 1456 | 1.4.2.4.1.1.2 | SIT Functional Testing End (non-MVC) (incl. confirmation that PPs have submitted their Test Completion Reports to Programme for assurance) | milestone | 0d | 2025-10-24 | 2025-10-24 | 1455FF |  |  | 2025-10-24 | 2025-10-24 | 0d | 2025-04-04 | 2025-04-04 | 25d | 0d |  | SI Test | PP | SIT | 6.0 | Roger Robar | Systems Integration Testing (SIT) | 358.71 | Green | AMBER | MHHS-ART072 | T3-TE-0052 | SITAG | T3 |  |
| 1457 | 1.4.2.4.1.2 | Assurance of PPs Test Completion Reports |  | 5d | 2025-11-03 | 2025-11-07 | 1456FS+5d |  |  | 2025-11-03 | 2025-11-07 | 5d | 2025-04-14 | 2025-04-18 | 25d | 0d |  | SI Test | PP | SIT | 6.0 | Roger Robar | Systems Integration Testing (SIT) | 368.33 | Green | GREEN |  |  |  |  |  |
| 1458 | 1.4.2.4.1.3 | **SIT Functional Testing Test Completion Report (non-MVC)** |  | 25d | 2025-10-06 | 2025-11-07 |  |  |  | 2025-10-06 | 2025-11-07 | 25d | 2025-03-17 | 2025-04-18 | 25d |  |  | N/A | N/A | SIT | 6.0 | N/A | Systems Integration Testing (SIT) |  |  |  |  |  |  |  |  |
| 1459 | 1.4.2.4.1.3.1 | Develop document |  | 15d | 2025-10-06 | 2025-10-24 | 1456FF |  |  | 2025-10-06 | 2025-10-24 | 15d | 2025-03-17 | 2025-04-04 | 30d | 5d |  | SI Test |  | SIT | 6.0 | Roger Robar | Systems Integration Testing (SIT) | 340.33 | Green | GREEN |  |  |  |  |  |
| 1460 | 1.4.2.4.1.3.2 | Review & agree document |  | 5d | 2025-11-03 | 2025-11-07 | 1459, 1457FF |  |  | 2025-11-03 | 2025-11-07 | 5d | 2025-04-14 | 2025-04-18 | 25d | 0d |  | SI Test | PP,IPA | SIT | 6.0 | Roger Robar | Systems Integration Testing (SIT) | 368.33 | Green | GREEN |  |  |  |  |  |
| 1461 | 1.4.2.4.1.4 | SIT Functional Testing Test Completion Report (non-MVC) Approved | milestone | 0d | 2025-11-14 | 2025-11-14 | 1460FF+5d |  |  | 2025-11-14 | 2025-11-14 | 0d | 2025-04-25 | 2025-04-25 | 25d | 0d |  | SI Test | PP | SIT | 6.0 | Roger Robar | Systems Integration Testing (SIT) | 379.71 | Green | AMBER | MHHS-ART072 | T3-TE-0055 | SITAG | T3 |  |
| 1462 | 1.4.2.4.2 | **SIT Migration Testing (non-MVC)** |  | 110d | 2025-06-16 A | 2025-11-14 |  | 23% | 85.25d | 2025-05-05 | 2025-10-08 | 230d | 2024-06-10 | 2025-04-25 | 25d |  |  | N/A | N/A | SIT | 6.0 | N/A | Systems Integration Testing (SIT) |  |  |  |  |  |  |  |  |
| 1463 | 1.4.2.4.2.1 | Test Execution (Cycle 3 Completion and Regression Testing) |  | 95d | 2025-06-16 A | 2025-10-24 | 1367 | 28% | 68d | 2025-05-05 | 2025-09-17 | 215d | 2024-06-10 | 2025-04-04 | 25d | 0d |  | SI Test | PP | SIT | 6.0 | Roger Robar | Systems Integration Testing (SIT) |  | Red | RED |  |  |  |  | D24E - Migration Test Completion Report |
| 1464 | 1.4.2.4.2.2 | SIT Migration Testing End (non-MVC) (incl. confirmation that PPs have submitted their Test Completion Reports to Programme for assurance) | milestone | 0d | 2025-10-24 | 2025-10-24 | 1463FF |  |  | 2025-09-17 | 2025-09-17 | 0d | 2025-04-04 | 2025-04-04 | 25d | 0d |  | SI Test | PP | SIT | 6.0 | Roger Robar | Systems Integration Testing (SIT) | 358.71 | Red | RED | MHHS-ART076 | T3-TE-0051 | SITAG | T3 |  |
| 1465 | 1.4.2.4.2.3 | Assurance of PPs Test Completion Reports |  | 5d | 2025-11-03 | 2025-11-07 | 1464FS+5d |  |  | 2025-09-25 | 2025-10-01 | 5d | 2025-04-14 | 2025-04-18 | 25d | 0d |  | SI Test | PP | SIT | 6.0 | Roger Robar | Systems Integration Testing (SIT) | 368.33 | Red | RED |  |  |  |  |  |
| 1466 | 1.4.2.4.2.4 | **SIT Migration Testing Test Completion Report (non-MVC)** |  | 25d | 2025-10-06 | 2025-11-07 |  |  |  | 2025-08-28 | 2025-10-01 | 25d | 2025-03-17 | 2025-04-18 | 25d |  |  | N/A | N/A | SIT | 6.0 | N/A | Systems Integration Testing (SIT) |  |  |  |  |  |  |  |  |
| 1467 | 1.4.2.4.2.4.1 | Develop document |  | 15d | 2025-10-06 | 2025-10-24 | 1464FF |  |  | 2025-08-28 | 2025-09-17 | 15d | 2025-03-17 | 2025-04-04 | 30d | 5d |  | SI Test |  | SIT | 6.0 | Roger Robar | Systems Integration Testing (SIT) | 340.33 | Red | RED |  |  |  |  |  |
| 1468 | 1.4.2.4.2.4.2 | Review & agree document |  | 5d | 2025-11-03 | 2025-11-07 | 1467, 1465FF |  |  | 2025-09-25 | 2025-10-01 | 5d | 2025-04-14 | 2025-04-18 | 25d | 0d |  | SI Test | PP,IPA | SIT | 6.0 | Roger Robar | Systems Integration Testing (SIT) | 368.33 | Red | RED |  |  |  |  |  |
| 1469 | 1.4.2.4.2.5 | SIT Migration Testing Test Completion Report (non-MVC Approved) | milestone | 0d | 2025-11-14 | 2025-11-14 | 1468FF+5d |  |  | 2025-10-08 | 2025-10-08 | 0d | 2025-04-25 | 2025-04-25 | 25d | 0d |  | SI Test | PP | SIT | 6.0 | Roger Robar | Systems Integration Testing (SIT) | 379.71 | Red | RED | MHHS-ART076 | T3-TE-0056 | SITAG | T3 |  |

Notes:
- 1447: 6/8/24: Date at risk due to lower than expected test velocity. Start of SIT Operational (MVC) could be delayed. Programme-wide scenario re-planning underway
- 1451: 6/8/24: Date at risk due to lower than expected test velocity. Start of SIT Operational (MVC) could be delayed. Programme-wide scenario re-planning underway
- 1456: 6/8/24: Date at risk due to lower than expected test velocity. Completion of SIT Functional Testing (Other Participants) could be delayed. Programme-wide scenario re-planning underway
- 1457: 6/8/24: Date at risk due to lower than expected test velocity. Completion of SIT Functional Testing (Other Participants) could be delayed. Programme-wide scenario re-planning underway
- 1459: 6/8/24: Date at risk due to lower than expected test velocity. Completion of SIT Functional Testing (Other Participants) could be delayed. Programme-wide scenario re-planning underway
- 1460: 6/8/24: Date at risk due to lower than expected test velocity. Completion of SIT Functional Testing (Other Participants) could be delayed. Programme-wide scenario re-planning underway
- 1461: 6/8/24: Date at risk due to lower than expected test velocity. Completion of SIT Functional Testing (Other Participants) could be delayed. Programme-wide scenario re-planning underway
- 1464: 6/8/24: Date at risk due to lower than expected test velocity. Completion of SIT Migration Testing (Other Participants) could be delayed. Programme-wide scenario re-planning underway
- 1469: 6/8/24: Date at risk due to lower than expected test velocity. Completion of SIT Migration Testing (Other Participants) could be delayed. Programme-wide scenario re-planning underway

| ID | WBS | Task | Type | Duration | Start | Finish | Predecessors | Complete | Remaining | Baseline start | Baseline finish | Baseline duration | Baseline 1 start | Baseline 1 finish | Total slack | Free slack | Constraint | Baseline cost | Responsible | Involved | Text9 | Update Version | MHHS Resource Name | MHHS Programme Phase | Task Status | Sched Status | RAG | Artefact ID | Milestone ID | Text29 | Tier |
| --- | --- | --- | --- | --- | --- | --- | --- | --- | --- | --- | --- | --- | --- | --- | --- | --- | --- | --- | --- | --- | --- | --- | --- | --- | --- | --- | --- | --- | --- | --- | --- |
| 1470 | 1.4.2.4.3 | **SIT non-MVC Test Exit Report** |  | 20d | 2025-10-27 | 2025-11-21 |  |  |  | 2025-10-27 | 2025-11-21 | 20d | 2025-03-17 | 2025-04-11 | 25d |  |  |  | N/A | N/A | SIT | 6.0 | N/A | Systems Integration Testing (SIT) |  |  |  |  |  |  |  |
| 1471 | 1.4.2.4.3.1 | Develop document |  | 15d | 2025-10-27 | 2025-11-14 | 1461FF, 1469FF |  |  | 2025-10-27 | 2025-11-14 | 15d | 2025-03-17 | 2025-04-04 | 25d | 0d |  |  | SI Test |  | SIT | 6.0 | Roger Robar | Systems Integration Testing (SIT) | 361.33 | Green | GREEN |  |  |  |  |
| 1472 | 1.4.2.4.3.2 | Review & agree document |  | 5d | 2025-11-17 | 2025-11-21 | 1471 |  |  | 2025-11-17 | 2025-11-21 | 5d | 2025-04-07 | 2025-04-11 | 25d | 0d |  |  | SI Test | PP,IPA | SIT | 6.0 | Roger Robar | Systems Integration Testing (SIT) | 382.33 | Green | GREEN |  |  |  |  |
| 1473 | 1.4.2.4.4 | SIT non-MVC Complete | milestone | 0d | 2025-11-27 | 2025-11-27 | 1472FS+4d, 1461, 1469 |  |  | 2025-11-27 | 2025-11-27 | 0d | 2025-04-21 | 2025-04-21 | 25d | 0d |  |  | SI Test | PP | SIT | 6.0 | Roger Robar | Systems Integration Testing (SIT) | 392.71 | Green | AMBER | MHHS-ART081 | T3-TE-0059 | SITAG | T3 |
| 1474 | 1.4.3 | **UIT Environment Preparation** |  | 700d? | 2022-10-31 A | 2025-07-04 |  | 46% | 379.53d? | 2022-10-31 | 2025-07-04 | 680d | 2022-10-31 | 2025-06-06 | 644d |  |  | -0 | N/A | N/A | SIT | 6.0 | N/A | Systems Integration Testing (SIT) |  |  |  |  |  |  |  |
| 1475 | 1.4.3.1 | **Test Artefact Development** |  | 556d? | 2023-03-01 A | 2025-04-16 |  | 51% | 270.06d? | 2023-03-01 | 2024-07-18 | 361d | 2023-03-01 | 2023-08-04 | 701d |  |  | -0 | N/A | N/A | SIT | 6.0 | N/A | Systems Integration Testing (SIT) |  |  |  |  |  |  |  |
| 1476 | 1.4.3.1.1 | **E2E Sandbox Guidance** |  | 539d? | 2023-03-01 A | 2025-03-24 |  | 71% | 158.53d? | 2023-03-01 | 2024-07-18 | 361d | 2023-03-01 | 2023-08-04 | 718d |  |  | -0 | N/A | N/A | SIT | 6.0 | N/A | Systems Integration Testing (SIT) |  |  |  |  |  |  |  |
| 1477 | 1.4.3.1.1.1 | Develop document |  | 83d | 2023-03-01 A | 2023-06-23 A |  | 100% |  | 2023-03-01 | 2023-06-23 | 83d | 2023-03-01 | 2023-06-23 |  |  | start no earlier than 2023-03-01 |  | SI Test |  | SIT | 6.0 | Stuart Scott | Systems Integration Testing (SIT) |  | Complete | COMPLETE |  |  |  |  |
| 1478 | 1.4.3.1.1.2 | Artefact review (via SITAG) and updates |  | 25d | 2023-06-26 A | 2023-07-28 A | 1477 | 100% |  | 2023-06-26 | 2023-07-28 | 25d | 2023-06-26 | 2023-07-28 |  |  |  |  | SI Test | PP,IPA | SIT | 6.0 | Stuart Scott | Systems Integration Testing (SIT) |  | Complete | COMPLETE |  |  |  |  |
| 1479 | 1.4.3.1.1.3 | E2E Sandbox Guidance approved | milestone | 0d | 2024-07-18 A | 2024-07-18 A | 1478FF+5d | 100% |  | 2024-07-18 | 2024-07-18 | 0d | 2023-08-04 | 2023-08-04 |  |  | start no earlier than 2024-07-18 |  | SI Test | PP | SIT | 6.0 | Stuart Scott | Systems Integration Testing (SIT) |  | Complete | COMPLETE | MHHS-ART154 | T3-TE-0067 | QAG | T3 |
| 1480 | 1.4.3.1.1.4 | Update E2E Sandbox guidance to reflect CR55 |  | 29d | 2025-01-13 | 2025-02-20 |  |  |  | 2025-01-13 | 2025-02-20 | 0d |  |  | 718d | 0d | start no earlier than 2025-01-13 |  |  |  | SIT | 6.1 |  |  | 74.33 | Green | GREEN |  |  |  |  |
| 1481 | 1.4.3.1.1.5 | Internal SI review |  | 5d | 2025-02-21 | 2025-02-27 | 1480 |  |  | 2025-02-21 | 2025-02-27 | 0d |  |  | 718d | 0d |  |  |  |  | SIT | 6.1 |  |  | 113.33 | Green | GREEN |  |  |  |  |
| 1482 | 1.4.3.1.1.6 | SRO / Code Bodies review |  | 5d | 2025-02-28 | 2025-03-06 | 1481 |  |  | 2025-02-28 | 2025-03-06 | 0d |  |  | 718d | 0d |  |  |  |  | SIT | 6.1 |  |  | 120.33 | Green | GREEN |  |  |  |  |
| 1483 | 1.4.3.1.1.7 | Submit version to QWG |  | 3d | 2025-03-07 | 2025-03-11 | 1482 |  |  | 2025-03-07 | 2025-03-11 | 0d |  |  | 718d | 0d |  |  |  |  | SIT | 6.1 |  |  | 127.33 | Green | GREEN |  |  |  |  |
| 1484 | 1.4.3.1.1.8 | Artefact Approval (via QWG) | milestone | 0d | 2025-03-11 | 2025-03-11 | 1483 |  |  | 2025-03-11 | 2025-03-11 | 0d |  |  | 718d | 0d |  |  |  |  | SIT | 6.1 |  |  | 131.71 | Green | GREEN |  |  |  |  |
| 1485 | 1.4.3.1.1.9 | Final Document updates post QWG review |  | 1d | 2025-03-13 | 2025-03-13 | 1484FS+1d |  |  | 2025-03-13 | 2025-03-13 | 0d |  |  | 718d | 0d |  |  |  |  | SIT | 6.1 |  |  | 133.33 | Green | GREEN |  |  |  |  |
| 1486 | 1.4.3.1.1.10 | Submit final version to QAG |  | 1d? | 2025-03-17 | 2025-03-17 | 1485FS+1d |  |  | 2025-03-17 | 2025-03-17 | 0d |  |  | 718d | 0d |  |  |  |  | SIT | 6.1 |  |  | 137.33 | Green | GREEN |  |  |  |  |
| 1487 | 1.4.3.1.1.11 | E2E Sandbox guidance update approved |  | 1d? | 2025-03-24 | 2025-03-24 | 1486FS+4d |  |  | 2025-03-24 | 2025-03-24 | 0d |  |  | 718d |  |  |  |  |  | SIT | 6.1 |  |  | 144.33 | Green | GREEN |  |  |  |  |
| 1488 | 1.4.3.1.2 | **E2E Sandbox Test Data Approach & Plan** |  | 68d | 2025-01-13 | 2025-04-16 |  |  |  | 2023-12-05 | 2024-05-09 | 93d | 2023-03-29 | 2023-08-04 | 701d |  |  |  | N/A | N/A | SIT | 6.1 | N/A | Systems Integration Testing (SIT) |  |  |  |  |  |  |  |
| 1489 | 1.4.3.1.2.1 | Develop document |  | 27d | 2025-01-13 | 2025-02-18 | 1477SS+199d |  |  | 2025-01-13 | 2025-02-18 | 68d | 2023-03-29 | 2023-06-30 | 701d | 0d | start no earlier than 2025-01-13 |  | SI Test |  | SIT | 5.0 | Stuart Scott | Systems Integration Testing (SIT) | 74.33 | Green | GREEN |  |  |  |  |
| 1490 | 1.4.3.1.2.2 | Internal SI review and updates |  | 5d | 2025-02-19 | 2025-02-25 | 1489 |  |  | 2025-02-19 | 2025-02-25 | 0d |  |  | 701d | 0d |  |  |  |  | SIT | 6.1 |  |  | 111.33 | Green | GREEN |  |  |  |  |
| 1491 | 1.4.3.1.2.3 | SRO / Code Bodies review |  | 5d | 2025-02-26 | 2025-03-04 | 1490 |  |  | 2025-02-26 | 2025-03-04 | 0d |  |  | 701d | 0d |  |  |  |  | SIT | 6.1 |  |  | 118.33 | Green | GREEN |  |  |  |  |
| 1492 | 1.4.3.1.2.4 | Submit proposed version to QWG | milestone | 0d | 2025-03-04 | 2025-03-04 | 1491 |  |  | 2025-03-04 | 2025-03-04 | 0d |  |  | 701d | 0d |  |  |  |  | SIT | 6.1 |  |  | 124.71 | Green | GREEN |  |  |  |  |
| 1493 | 1.4.3.1.2.5 | Discuss document at QWG | milestone | 0d | 2025-03-11 | 2025-03-11 | 1492FS+5d |  |  | 2025-03-11 | 2025-03-11 | 0d |  |  | 701d | 0d |  |  |  |  | SIT | 6.1 |  |  | 131.71 | Green | GREEN |  |  |  |  |
| 1494 | 1.4.3.1.2.6 | Final updates prior to consultation |  | 4d | 2025-03-12 | 2025-03-17 | 1493 |  |  | 2025-03-12 | 2025-03-17 | 0d |  |  | 701d | 0d |  |  |  |  | SIT | 6.1 |  |  | 132.33 | Green | GREEN |  |  |  |  |
| 1495 | 1.4.3.1.2.7 | Industry Consultation for E2E Sandbox Test Data Approach and Plan document |  | 10d | 2025-03-18 | 2025-03-31 | 1494 |  |  | 2025-03-18 | 2025-03-31 | 0d |  |  | 701d | 0d |  |  |  |  | SIT | 6.1 |  |  | 138.33 | Green | GREEN |  |  |  |  |
| 1496 | 1.4.3.1.2.8 | Document updates post Industry Consultation |  | 3d | 2025-04-01 | 2025-04-03 | 1495 |  |  | 2025-04-01 | 2025-04-03 | 0d |  |  | 701d | 0d | finish no earlier than 2024-04-22 |  |  |  | SIT | 6.1 |  |  | 152.33 | Green | GREEN |  |  |  |  |
| 1497 | 1.4.3.1.2.9 | Submit Proposed Version to QWG |  | 3d | 2025-04-04 | 2025-04-08 | 1496 |  |  | 2025-04-04 | 2025-04-08 | 0d |  |  | 701d | 0d |  |  |  |  | SIT | 6.1 |  |  | 155.33 | Green | GREEN |  |  |  |  |
| 1498 | 1.4.3.1.2.10 | Artefact Approval (via QWG) | milestone | 0d | 2025-04-08 | 2025-04-08 | 1497 |  |  | 2025-04-08 | 2025-04-08 | 0d |  |  | 701d | 0d |  |  |  |  | SIT | 6.1 |  |  | 159.71 | Green | GREEN |  |  |  |  |
| 1499 | 1.4.3.1.2.11 | Final Document updates post QWG review | milestone | 0d | 2025-04-09 | 2025-04-09 | 1498FS+1d |  |  | 2025-04-09 | 2025-04-09 | 0d |  |  | 701d | 0d | start no earlier than 2024-05-01 |  |  |  | SIT | 6.1 |  |  | 160.71 | Green | GREEN |  |  |  |  |
| 1500 | 1.4.3.1.2.12 | Submit final version to QAG | milestone | 0d | 2025-04-10 | 2025-04-10 | 1499FS+1d |  |  | 2025-04-10 | 2025-04-10 | 0d |  |  | 701d | 0d | start no earlier than 2024-05-02 |  |  |  | SIT | 6.1 |  |  | 161.71 | Green | GREEN |  |  |  |  |
| 1501 | 1.4.3.1.2.13 | E2E Sandbox Test Data Approach and Plan | milestone | 0d | 2025-04-16 | 2025-04-16 | 1500FS+4d |  |  | 2025-04-16 | 2025-04-16 | 0d |  |  | 701d |  | start no earlier than 2024-05-09 |  |  |  | SIT | 6.1 |  |  | 167.71 | Green | GREEN |  | T3-QU-0124 |  |  |

Notes:
- 1471: 6/8/24: Date at risk due to lower than expected test velocity. Completion of SIT- Other Particiapnts Test Exit report could be delayed. Programme-wide scenario re-planning underway
- 1472: 6/8/24: Date at risk due to lower than expected test velocity. Completion of SIT- Other Particiapnts Test Exit report could be delayed. Programme-wide scenario re-planning underway
- 1473: 6/8/24: Date at risk due to lower than expected test velocity. Completion of SIT- Other Particiapnts Test Exit report could be delayed. Programme-wide scenario re-planning underway
- 1479: 26/6: Baseline date change approved at QAG on 20/6/24. 11/7/24: Date change approved at QAG on 20/6/24 from 4/08/24 to 18/7/24

| ID | WBS | Task | Type | Duration | Start | Finish | Predecessors | Complete | Remaining | Baseline start | Baseline finish | Baseline duration | Baseline 1 start | Baseline 1 finish | Total slack | Free slack | Constraint | Baseline cost | Responsible | Involved | Text9 | Update Version | MHHS Resource Name | MHHS Programme Phase | Sched Status | RAG | Artefact ID | Task Status | Milestone ID | Text29 | Tier |
| --- | --- | --- | --- | --- | --- | --- | --- | --- | --- | --- | --- | --- | --- | --- | --- | --- | --- | --- | --- | --- | --- | --- | --- | --- | --- | --- | --- | --- | --- | --- | --- |
| 1502 | 1.4.3.2 | **UIT Stub Specification and Delivery** |  | 260d | 2023-12-04 A | 2024-11-29 |  | 79% | 55.35d | 2023-12-04 | 2024-10-18 | 190d | 2023-10-27 | 2024-08-23 | 799d |  |  | -0 | N/A | N/A | SIT | 5.0 | N/A | Systems Integration Testing (SIT) |  |  |  |  |  |  |  |
| 1503 | 1.4.3.2.1 | **Qualification Test Stubs** |  | 260d | 2023-12-04 A | 2024-11-29 |  | 79% | 55.35d | 2023-12-04 | 2024-10-18 | 190d | 2023-10-27 | 2024-08-23 | 799d |  |  | -0 | N/A | N/A | SIT | 5.16 | N/A | Systems Integration Testing (SIT) |  |  |  |  |  |  |  |
| 1504 | 1.4.3.2.1.1 | Specify |  | 44d | 2023-12-04 A | 2024-02-01 A | 512FS+13d | 100% |  | 2023-12-04 | 2024-02-01 | 44d | 2023-10-27 | 2023-12-29 |  |  |  |  | SI DevOps | Qualification,SRO | SIT | 5.0 | Matthew Bray | Systems Integration Testing (SIT) | Complete | COMPLETE |  |  |  |  |  |
| 1505 | 1.4.3.2.1.2 | Build & Test |  | 141d | 2024-02-02 A | 2024-08-16 | 1504 | 90% | 14.1d | 2024-02-02 | 2024-08-16 | 141d | 2023-12-29 | 2024-05-24 | 33.75d | 0d |  |  | SI DevOps | Qualification,SRO | SIT | 5.23 | Matthew Bray | Systems Integration Testing (SIT) | Overdue | RED |  |  |  |  |  |
| 1506 | 1.4.3.2.1.3 | Prepare for release |  | 75d | 2024-08-19 A | 2024-11-29 | 1505 | 45% | 41.25d | 2024-08-19 | 2024-11-29 | 5d | 2024-07-29 | 2024-08-23 | 799d | 0d |  |  | SI DevOps | Qualification,SRO | SIT | 5.0 | Matthew Bray | Systems Integration Testing (SIT) | Green | GREEN |  |  |  |  |  |
| 1507 | 1.4.3.2.1.4 | Non-SIT LDSO Test Harness Released | milestone | 0d | 2024-11-29 | 2024-11-29 | 1506 |  |  | 2024-11-29 | 2024-11-29 | 0d | 2024-08-23 | 2024-08-23 | 799d |  |  |  | SI DevOps | Qualification,SRO | SIT | 5.27 | Matthew Bray | Systems Integration Testing (SIT) | Green | GREEN | MHHS-ART080 | 29.71 | T3-TE-0035 | QAG | T3 |
| 1508 | 1.4.3.3 | **Environments (UIT)** |  | 700d | 2022-10-31 A | 2025-07-04 |  | 44% | 389.54d | 2022-10-31 | 2025-07-04 | 680d | 2022-10-31 | 2025-06-06 | 644d |  |  | -0 | N/A | N/A | SIT | 5.0 | N/A | Systems Integration Testing (SIT) |  |  |  |  |  |  |  |
| 1509 | 1.4.3.3.1 | **Central Party (Avenade) Environments (UIT)** |  | 488d | 2022-11-16 A | 2024-09-27 |  | 97% | 14.82d | 2022-11-16 | 2024-09-27 | 493d | 2022-11-16 | 2024-10-04 | 844d |  |  | -0 | N/A | N/A | SIT | 5.28 | N/A | Systems Integration Testing (SIT) |  |  |  |  |  |  |  |
| 1510 | 1.4.3.3.1.1 | Central Party (Avendae) environment preparation (incl. security certificates and security compliance) |  | 447d | 2022-11-16 A | 2024-08-01 A | 508 | 100% |  | 2022-11-16 | 2024-08-01 | 463d | 2022-11-16 | 2024-08-23 |  |  |  |  | PP | SI Test | SIT | 5.28 | Simon Berry | Systems Integration Testing (SIT) | Complete | COMPLETE |  |  |  |  |  |
| 1511 | 1.4.3.3.1.2 | Submit self-declaration of environment preparation complete (incl. security certificates and security compliance) to Programme for assurance |  | 447d | 2022-11-16 A | 2024-08-01 A | 1510SS | 100% |  | 2022-11-16 | 2024-08-01 | 463d | 2022-11-16 | 2024-08-23 |  |  |  |  | PP | SI Test | SIT | 5.28 | Simon Berry | Systems Integration Testing (SIT) | Complete | COMPLETE |  |  |  |  |  |
| 1512 | 1.4.3.3.1.3 | Central Party (Avenade) UIT environment connectivity proving |  | 25d | 2024-08-26 | 2024-09-27 | 1524 |  |  | 2024-08-26 | 2024-09-27 | 25d | 2024-08-27 | 2024-09-20 | 843d | 0d |  |  | PP | SI Test | SIT | 5.28 | Simon Berry | Systems Integration Testing (SIT) | Overdue Start | RED |  | -65.67 |  |  |  |
| 1513 | 1.4.3.3.1.4 | Deployment of MHHS solution code to UIT environments |  | 2d | 2024-07-29 | 2024-07-30 |  |  |  | 2024-07-29 | 2024-07-30 | 10d | 2024-09-09 | 2024-09-20 | 886d | 0d | start no earlier than 2024-07-29 |  | PP | SI Test | SIT | 5.28 | Simon Berry | Systems Integration Testing (SIT) | Overdue Start | RED |  | -93.67 |  |  |  |
| 1514 | 1.4.3.3.1.5 | Central Party (Avenade) UIT environment Regression Testing |  | 1d | 2024-07-31 | 2024-07-31 | 1513 |  |  | 2024-07-31 | 2024-07-31 | 10d | 2024-09-23 | 2024-10-04 | 886d |  |  |  | PP | SI Test | SIT | 5.28 | Simon Berry | Systems Integration Testing (SIT) | Overdue Start | RED |  | -91.67 |  |  |  |
| 1515 | 1.4.3.3.2 | **E2E Sandbox Participants (UIT)** |  | 680d | 2022-10-31 | 2025-06-06 |  |  |  | 2022-10-31 | 2025-06-06 | 680d | 2022-10-31 | 2025-06-06 | 0d |  |  |  | N/A | N/A | SIT | 5.0 | N/A | Systems Integration Testing (SIT) |  |  |  |  |  |  |  |
| 1516 | 1.4.3.3.2.1 | E2E Sandbox Participants environment preparation (incl. security certificates and security compliance) |  | 660d | 2022-10-31 | 2025-05-09 |  |  |  | 2022-10-31 | 2025-05-09 | 660d | 2022-10-31 | 2025-05-09 | 0d |  | must finish on 2025-05-09 |  | PP | SI Test | SIT | 5.0 | Simon Berry | Systems Integration Testing (SIT) | Overdue Start | GREEN |  | -730.67 |  |  |  |
| 1517 | 1.4.3.3.2.2 | Submit self-declaration of environment preparation complete (incl. security certificates and security compliance) to Programme for assurance |  | 660d | 2022-10-31 | 2025-05-09 |  |  |  | 2022-10-31 | 2025-05-09 | 660d | 2022-10-31 | 2025-05-09 | 664d | 0d |  |  | PP | SI Test | SIT | 5.0 | Simon Berry | Systems Integration Testing (SIT) | Overdue Start | GREEN |  | -730.67 |  |  |  |
| 1518 | 1.4.3.3.2.3 | E2E Sandbox Participants UIT environment connectivity proving |  | 20d | 2025-05-12 | 2025-06-06 | 1517 |  |  | 2025-05-12 | 2025-06-06 | 20d | 2025-05-12 | 2025-06-06 | 664d | 0d |  |  | PP | SI Test | SIT | 5.0 | Simon Berry | Systems Integration Testing (SIT) | Green | GREEN |  | 193.33 |  |  |  |
| 1519 | 1.4.3.3.2.4 | Deployment of MHHS solution code to UIT environments |  | 10d | 2025-05-26 | 2025-06-06 | 1518FF |  |  | 2025-05-26 | 2025-06-06 | 10d | 2025-05-26 | 2025-06-06 | 664d |  |  |  | PP | SI Test | SIT | 5.0 | Simon Berry | Systems Integration Testing (SIT) | Green | GREEN |  | 207.33 |  |  |  |
| 1520 | 1.4.3.3.2.5 | Coordinate E2E Sandbox Participants' UIT environment preparation (for E2E Sandbox Testing Start) |  | 463d | 2022-10-31 | 2024-08-07 | 1516SS |  |  | 2022-10-31 | 2024-08-07 | 463d | 2022-10-31 | 2024-08-07 | 881d |  |  |  | SI Test | PP | SIT | 5.0 | Simon Berry | Systems Integration Testing (SIT) | Overdue Start | RED |  | -730.67 |  |  |  |
| 1521 | 1.4.3.3.3 | **SI Environments (UIT)** |  | 688d | 2022-11-16 A | 2025-07-04 |  | 69% | 215.33d | 2022-11-16 | 2025-07-04 | 680d | 2022-10-31 | 2025-06-06 | 644d |  |  |  | N/A | N/A | SIT | 5.0 | N/A | Systems Integration Testing (SIT) |  |  |  |  |  |  |  |
| 1522 | 1.4.3.3.3.1 | Coordinate Central Parties' UIT environment preparation |  | 447d | 2022-11-16 A | 2024-08-01 A | 1510SS | 100% |  | 2022-11-16 | 2024-08-01 | 463d | 2022-11-16 | 2024-08-23 |  |  |  |  | SI Test | PP | SIT | 5.0 | Simon Berry | Systems Integration Testing (SIT) | Complete | COMPLETE |  |  |  |  |  |
| 1523 | 1.4.3.3.3.2 | Assure Central Parties' self-declaration of environment preparation complete (incl. security certificates and security compliance) |  | 463d | 2022-11-16 A | 2024-08-23 | 1511SS | 97% | 12d | 2022-11-16 | 2024-08-23 | 463d | 2022-11-16 | 2024-08-23 | 869d |  |  |  | SI Test | PP | SIT | 5.0 | Simon Berry | Systems Integration Testing (SIT) | Overdue | RED |  |  |  |  |  |
| 1524 | 1.4.3.3.3.3 | Central Parties' UIT environments ready to start connectivity proving (incl. certificates and security compliance) | milestone | 0d | 2024-08-23 A | 2024-08-23 A | 1507 | 100% |  | 2024-08-23 | 2024-08-23 | 0d | 2024-08-23 | 2024-08-23 |  |  |  |  | SI Test | PP | SIT | 5.0 | Simon Berry | Systems Integration Testing (SIT) | Complete | COMPLETE |  |  | T3-TE-0044 | QAG | T3 |
| 1525 | 1.4.3.3.3.4 | Coordinate Central Parties' UIT environment connectivity proving |  | 26d | 2024-08-26 | 2024-09-30 | 1512SS |  |  | 2024-08-26 | 2024-09-30 | 19d | 2025-05-12 | 2025-06-05 | 843d |  |  |  | SI Test | PP | SIT | 5.0 | Simon Berry | Systems Integration Testing (SIT) | Overdue Start | RED |  | -65.67 |  |  |  |
| 1526 | 1.4.3.3.3.5 | Coordinate deployment of MHHS solution code to Central Parties' UIT environments |  | 2d | 2024-07-29 A | 2024-07-30 A | 1513SS | 100% |  | 2024-07-29 | 2024-07-30 | 10d | 2025-05-26 | 2025-06-06 |  |  |  |  | SI Test | PP | SIT | 5.0 | Simon Berry | Systems Integration Testing (SIT) | Complete | COMPLETE |  |  |  |  |  |
| 1527 | 1.4.3.3.3.6 | Coordinate Central Parties' UIT environment Regression Testing |  | 1d | 2024-07-31 | 2024-07-31 | 1526 |  |  | 2024-07-31 | 2024-07-31 | 10d | 2024-09-23 | 2024-10-04 | 886d |  |  |  | SI Test | PP | SIT | 5.0 | Simon Berry | Systems Integration Testing (SIT) | Overdue Start | RED |  | -91.67 |  |  |  |

Notes:
- 1505: 30/4: Removed previous testing phases as were no longer relevant and extended task to push out to align with existing dates
- 1507: Date will be missed due to Sims & Ems being blocked from completing connectivity and regression testing activities, since message functionality is disabled in the current UIT environment version (IR7.3), only becoming enabled from 2/9 (release of IR8.1 UIT). Decision not to seek milestone date change and RAG as red was requested by SRO, with a corresponding acknowledgement that Sims & Ems are blocked due to external factors. LDP working towards getting the milestone date changed to September (exact date TBC). / Notes (2): 9/8/24: the meantime, and acknowledges that the reason for this is due to external factors (being blocked from completing final delivery activities due to UIT functionality until September) rather than S&E missing the deadline
- 1509: 8/7/24: Updated to reflect Avende are the only PP

| ID | WBS | Task | Type | Duration | Start | Finish | Predecessors | Baseline start | Baseline finish | Baseline duration | Baseline 1 start | Baseline 1 finish | Total slack | Free slack | Constraint | Responsible | Involved | Text9 | Update Version | MHHS Resource Name | MHHS Programme Phase | Task Status | Sched Status | RAG | Artefact ID | Milestone ID | Text29 | Tier |
| --- | --- | --- | --- | --- | --- | --- | --- | --- | --- | --- | --- | --- | --- | --- | --- | --- | --- | --- | --- | --- | --- | --- | --- | --- | --- | --- | --- | --- |
| 1528 | 1.4.3.3.3.7 | **Environments (Non-SIT LDSO)** |  | 43d | 2024-08-01 | 2024-09-30 |  | 2024-08-01 | 2024-09-30 | 115d | 2024-08-06 | 2025-01-13 | 843d |  |  | N/A | N/A | SIT | 5.28 | N/A | Qualification |  |  |  |  |  |  |  |
| 1529 | 1.4.3.3.3.7.1 | Coordinate Qualification Participants' environment preparation |  | 17d | 2024-08-01 | 2024-08-23 |  | 2024-08-01 | 2024-08-23 | 60d | 2024-08-06 | 2024-10-28 | 869d |  | start no earlier than 2024-08-01 | SI Test | Code Bodies, PP | SIT | 5.28 | Simon Berry | Qualification | -90.67 | Overdue Start | RED |  |  |  |  |
| 1530 | 1.4.3.3.3.7.2 | Coordinate deployment of MHHS solution code to Qualification Participants' UIT environments |  | 17d | 2024-08-01 | 2024-08-23 |  | 2024-08-01 | 2024-08-23 | 10d | 2024-10-15 | 2024-10-28 | 843d | 0d | start no earlier than 2024-08-01 | SI Test | Code Bodies, PP | SIT | 5.28 | Simon Berry | Qualification | -90.67 | Overdue Start | RED |  |  |  |  |
| 1531 | 1.4.3.3.3.7.3 | Qualification Testing Tranche 1 Participants' UIT environments ready to start connectivity proving (incl. certificates and security compliance) | milestone | 0d | 2024-08-26 | 2024-08-26 | 1530FS+1d | 2024-08-26 | 2024-08-26 | 0d | 2024-11-04 | 2024-11-04 | 843d | 0d |  | SI Test | Code Bodies, PP, IPA | SIT | 5.28 | Simon Berry | Qualification | -65.29 | Overdue Start | RED | MHHS-ART073 | T3-QU-0017 | QAG | T3 |
| 1532 | 1.4.3.3.3.7.4 | **Coordinate Qualification Participants' connectivity proving (Non-SIT LDSO)** |  | 25d | 2024-08-27 | 2024-09-30 |  | 2024-08-27 | 2024-09-30 | 50d | 2024-11-05 | 2025-01-13 | 843d |  |  | N/A | N/A | SIT | 5.0 | N/A | Qualification |  |  |  |  |  |  |  |
| 1533 | 1.4.3.3.3.7.4.1 | Assurance of Qualification Participants' connectivity proving |  | 25d | 2024-08-27 | 2024-09-30 | 1531 | 2024-08-27 | 2024-09-30 | 50d | 2024-11-05 | 2025-01-13 | 843d |  |  | SI Test | Code Bodies, PP | SIT | 5.0 |  | Qualification | -64.67 | Overdue Start | RED |  |  |  |  |
| 1534 | 1.4.3.3.3.8 | **Environments (S&A) Wave 1** |  | 41d | 2024-08-01 | 2024-09-26 |  | 2024-08-01 | 2024-09-26 | 115d | 2024-08-06 | 2025-01-13 |  |  |  | N/A | N/A | SIT | 5.28 | N/A | Qualification |  |  |  |  |  |  |  |
| 1535 | 1.4.3.3.3.8.1 | Coordinate Qualification Participants' environment preparation |  | 20d | 2024-09-02 | 2024-09-27 |  | 2024-09-02 | 2024-09-27 | 60d | 2024-08-06 | 2024-10-28 | 844d |  | start no earlier than 2024-09-02 | SI Test | Code Bodies, PP | SIT | 5.28 | Simon Berry | Qualification | -58.67 | Overdue Start | RED |  |  |  |  |
| 1536 | 1.4.3.3.3.8.2 | Coordinate deployment of MHHS solution code to Qualification Participants' UIT environments |  | 10d | 2024-10-21 | 2024-11-01 |  | 2024-10-21 | 2024-11-01 | 10d | 2024-10-15 | 2024-10-28 | 774d | 0d | start no earlier than 2024-10-21 | SI Test | Code Bodies, PP | SIT | 5.28 | Simon Berry | Qualification | -9.67 | Overdue Start | GREEN |  |  |  |  |
| 1537 | 1.4.3.3.3.8.3 | Qualification Testing Wave 1 Participants' UIT environments ready to start connectivity proving (incl. certificates and security compliance) |  | 19d | 2024-11-05 | 2024-11-29 | 1536FS+1d | 2024-11-05 | 2024-11-29 | 0d | 2024-11-04 | 2024-11-04 | 774d | 0d |  | SI Test | Code Bodies, PP, IPA | SIT | 5.28 | Simon Berry | Qualification | 5.33 | Green | GREEN | MHHS-ART073 | New? | QAG | T3 |
| 1538 | 1.4.3.3.3.8.4 | **Coordinate Qualification Participants' connectivity proving (S&A)** |  | 25d | 2024-12-02 | 2025-01-03 |  | 2024-12-02 | 2025-01-03 | 50d | 2024-11-05 | 2025-01-13 | 774d |  |  | N/A | N/A | SIT | 5.0 | N/A | Qualification |  |  |  |  |  |  |  |
| 1539 | 1.4.3.3.3.8.4.1 | Assurance of Qualification Participants' connectivity proving |  | 25d | 2024-12-02 | 2025-01-03 | 1537 | 2024-12-02 | 2025-01-03 | 50d | 2024-11-05 | 2025-01-13 | 774d |  |  | SI Test | Code Bodies, PP | SIT | 5.0 |  | Qualification | 32.33 | Green | GREEN |  |  |  |  |
| 1540 | 1.4.3.3.3.9 | **Environments (S&A) Wave 2** |  | 139d | 2024-08-27 | 2025-03-07 |  | 2024-08-27 | 2025-03-07 | 115d | 2024-08-06 | 2025-01-13 | 0d |  |  | N/A | N/A | SIT | 5.28 | N/A | Qualification |  |  |  |  |  |  |  |
| 1541 | 1.4.3.3.3.9.1 | Coordinate Qualification Participants' environment preparation |  | 20d | 2024-11-18 | 2024-12-13 |  | 2024-11-18 | 2024-12-13 | 60d | 2024-08-06 | 2024-10-28 | 789d |  | start no earlier than 2024-11-18 | SI Test | Code Bodies, PP | SIT | 5.28 | Simon Berry | Qualification | 18.33 | Green | GREEN |  |  |  |  |
| 1542 | 1.4.3.3.3.9.2 | Coordinate deployment of MHHS solution code to Qualification Participants' UIT environments |  | 20d | 2024-12-16 | 2025-01-10 |  | 2024-12-16 | 2025-01-10 | 10d | 2024-10-15 | 2024-10-28 | 729d | 0d | start no earlier than 2024-12-16 | SI Test | Code Bodies, PP | SIT | 5.28 | Simon Berry | Qualification | 46.33 | Green | GREEN |  |  |  |  |
| 1543 | 1.4.3.3.3.9.3 | Qualification Testing Wave 2 Participants' UIT environments ready to start connectivity proving (incl. certificates and security compliance) |  | 15d | 2025-01-13 | 2025-01-31 | 1542 | 2025-01-13 | 2025-01-31 | 0d | 2024-11-04 | 2024-11-04 | 729d | 0d |  | SI Test | Code Bodies, PP, IPA | SIT | 5.28 | Simon Berry | Qualification | 74.33 | Green | GREEN | MHHS-ART073 | New? | QAG | T3 |
| 1544 | 1.4.3.3.3.9.4 | **Coordinate Qualification Participants' connectivity proving (S&A)** |  | 25d | 2024-08-27 | 2024-09-30 |  | 2024-08-27 | 2024-09-30 | 50d | 2024-11-05 | 2025-01-13 |  |  |  | N/A | N/A | SIT | 5.0 | N/A | Qualification |  |  |  |  |  |  |  |
| 1545 | 1.4.3.3.3.9.4.1 | Assurance of Qualification Participants' connectivity proving |  | 25d | 2025-02-03 | 2025-03-07 | 1543 | 2025-02-03 | 2025-03-07 | 50d | 2024-11-05 | 2025-01-13 | 729d |  |  | SI Test | Code Bodies, PP | SIT | 5.0 |  | Qualification | 95.33 | Green | GREEN |  |  |  |  |
| 1546 | 1.4.3.3.3.10 | **Environments (S&A) Wave 3** |  | 80d | 2025-03-17 | 2025-07-04 |  | 2025-03-17 | 2025-07-04 | 115d | 2024-08-06 | 2025-01-13 | 644d |  |  | N/A | N/A | SIT | 5.28 | N/A | Qualification |  |  |  |  |  |  |  |
| 1547 | 1.4.3.3.3.10.1 | Coordinate Qualification Participants' environment preparation |  | 30d | 2025-03-17 | 2025-04-25 |  | 2025-03-17 | 2025-04-25 | 60d | 2024-08-06 | 2024-10-28 | 694d |  | start no earlier than 2025-03-17 | SI Test | Code Bodies, PP | SIT | 5.28 | Simon Berry | Qualification | 137.33 | Green | GREEN |  |  |  |  |
| 1548 | 1.4.3.3.3.10.2 | Coordinate deployment of MHHS solution code to Qualification Participants' UIT environments |  | 10d | 2025-04-28 | 2025-05-09 |  | 2025-04-28 | 2025-05-09 | 10d | 2024-10-15 | 2024-10-28 | 644d | 0d | start no earlier than 2025-04-28 | SI Test | Code Bodies, PP | SIT | 5.28 | Simon Berry | Qualification | 179.33 | Green | GREEN |  |  |  |  |
| 1549 | 1.4.3.3.3.10.3 | Qualification Testing Wave 3 Participants' UIT environments ready to start connectivity proving (incl. certificates and security compliance) |  | 14d | 2025-05-13 | 2025-05-30 | 1548FS+1d | 2025-05-13 | 2025-05-30 | 0d | 2024-11-04 | 2024-11-04 | 644d | 0d |  | SI Test | Code Bodies, PP, IPA | SIT | 5.28 | Simon Berry | Qualification | 194.33 | Green | GREEN | MHHS-ART073 | New? | QAG | T3 |
| 1550 | 1.4.3.3.3.10.4 | **Coordinate Qualification Participants' connectivity proving (S&A)** |  | 25d | 2025-06-02 | 2025-07-04 |  | 2025-06-02 | 2025-07-04 | 50d | 2024-11-05 | 2025-01-13 | 644d |  |  | N/A | N/A | SIT | 5.0 | N/A | Qualification |  |  |  |  |  |  |  |
| 1551 | 1.4.3.3.3.10.4.1 | Assurance of Qualification Participants' connectivity proving |  | 25d | 2025-06-02 | 2025-07-04 | 1549 | 2025-06-02 | 2025-07-04 | 50d | 2024-11-05 | 2025-01-13 | 644d |  |  | SI Test | Code Bodies, PP | SIT | 5.0 |  | Qualification | 214.33 | Green | GREEN |  |  |  |  |

Notes:
- 1528: 8/7/24: Updated to reflect the separation between non-sit and s and a and the 4 waves for s and a
- 1529: 8/7/24: Updated to reflect the separation between non-sit and s and a and the 4 waves for s and a
- 1530: 8/7/24: Updated to reflect the separation between non-sit and s and a and the 4 waves for s and a
- 1531: 8/7/24: Updated to reflect the separation between non-sit and s and a and the 4 waves for s and a
- 1534: 8/7/24: Updated to reflect the separation between non-sit and s and a and the 4 waves for s and a
- 1535: 8/7/24: Updated to reflect the separation between non-sit and s and a and the 4 waves for s and a
- 1536: 8/7/24: Updated to reflect the separation between non-sit and s and a and the 4 waves for s and a
- 1537: 8/7/24: Updated to reflect the separation between non-sit and s and a and the 4 waves for s and a
- 1540: 8/7/24: Updated to reflect the separation between non-sit and s and a and the 4 waves for s and a
- 1541: 8/7/24: Updated to reflect the separation between non-sit and s and a and the 4 waves for s and a
- 1542: 8/7/24: Updated to reflect the separation between non-sit and s and a and the 4 waves for s and a
- 1543: 8/7/24: Updated to reflect the separation between non-sit and s and a and the 4 waves for s and a
- 1546: 8/7/24: Updated to reflect the separation between non-sit and s and a and the 4 waves for s and a
- 1547: 8/7/24: Updated to reflect the separation between non-sit and s and a and the 4 waves for s and a
- 1548: 8/7/24: Updated to reflect the separation between non-sit and s and a and the 4 waves for s and a
- 1549: 8/7/24: Updated to reflect the separation between non-sit and s and a and the 4 waves for s and a

| ID | WBS | Task | Duration | Start | Finish | Predecessors | Complete | Remaining | Baseline start | Baseline finish | Baseline duration | Baseline 1 start | Baseline 1 finish | Total slack | Free slack | Constraint | Baseline cost | Responsible | Involved | Text9 | Update Version | MHHS Resource Name | MHHS Programme Phase | Task Status | Sched Status | RAG | Artefact ID | Milestone ID | Text29 | Tier |
| --- | --- | --- | --- | --- | --- | --- | --- | --- | --- | --- | --- | --- | --- | --- | --- | --- | --- | --- | --- | --- | --- | --- | --- | --- | --- | --- | --- | --- | --- | --- |
| 1552 | 1.4.3.3.3.11 | **Environments (S&A) Wave 4** | 80d | 2025-03-17 | 2025-07-04 |  |  |  | 2025-03-17 | 2025-07-04 | 115d | 2024-08-06 | 2025-01-13 | 55d |  |  |  | N/A | N/A | SIT | 5.28 | N/A | Qualification |  |  |  |  |  |  |  |
| 1553 | 1.4.3.3.3.11.1 | Coordinate Qualification Participants' environment preparation | 30d | 2025-03-17 | 2025-04-25 |  |  |  | 2025-03-17 | 2025-04-25 | 60d | 2024-08-06 | 2024-10-28 | 694d |  | finish no earlier than 2025-04-25 |  | SI Test | Code Bodies, PP | SIT | 5.28 | Simon Berry | Qualification | 137.33 | Green | GREEN |  |  |  |  |
| 1554 | 1.4.3.3.3.11.2 | Coordinate deployment of MHHS solution code to Qualification Participants' UIT environments | 10d | 2025-04-28 | 2025-05-09 |  |  |  | 2025-04-28 | 2025-05-09 | 10d | 2024-10-15 | 2024-10-28 | 644d | 0d | finish no earlier than 2025-05-09 |  | SI Test | Code Bodies, PP | SIT | 5.28 | Simon Berry | Qualification | 179.33 | Green | GREEN |  |  |  |  |
| 1555 | 1.4.3.3.3.11.3 | Qualification Testing Wave 4 Participants' UIT environments ready to start connectivity proving (incl. certificates and security compliance) | 14d | 2025-05-13 | 2025-05-30 | 1554FS+1d |  |  | 2025-05-13 | 2025-05-30 | 0d | 2024-11-04 | 2024-11-04 | 644d | 0d | finish no earlier than 2025-05-30 |  | SI Test | Code Bodies, PP, IPA | SIT | 5.28 | Simon Berry | Qualification | 194.33 | Green | GREEN | MHHS-ART073 | New? | QAG | T3 |
| 1556 | 1.4.3.3.3.11.4 | **Coordinate Qualification Participants' connectivity proving (S&A)** | 25d | 2025-06-02 | 2025-07-04 |  |  |  | 2025-06-02 | 2025-07-04 | 50d | 2024-11-05 | 2025-01-13 |  |  |  |  | N/A | N/A | SIT | 5.0 | N/A | Qualification |  |  |  |  |  |  |  |
| 1557 | 1.4.3.3.3.11.4.1 | Assurance of Qualification Participants' connectivity proving | 25d | 2025-06-02 | 2025-07-04 | 1555 |  |  | 2025-06-02 | 2025-07-04 | 50d | 2024-11-05 | 2025-01-13 | 644d |  | start no earlier than 2025-06-02 |  | SI Test | Code Bodies, PP | SIT | 5.0 |  | Qualification | 214.33 | Green | GREEN |  |  |  |  |
| 1558 | 1.4.3.4 | **Test Data** | 30d | 2024-08-26 | 2024-10-04 |  |  |  | 2024-08-26 | 2024-10-04 | 30d | 2024-08-26 | 2024-10-04 | 819d |  |  | -0 | N/A | N/A | SIT | 5.0 | N/A | Systems Integration Testing (SIT) |  |  |  |  |  |  |  |
| 1559 | 1.4.3.4.1 | **Central Parties (for E2E Sandbox & Qualification)** | 30d | 2024-08-26 | 2024-10-04 |  |  |  | 2024-08-26 | 2024-10-04 | 30d | 2024-08-26 | 2024-10-04 | 819d |  |  |  | N/A | N/A | SIT | 5.0 | N/A | Systems Integration Testing (SIT) |  |  |  |  |  |  |  |
| 1560 | 1.4.3.4.1.1 | Central Parties' UIT environment test data loading & verification (& data cleansing, if required) | 30d | 2024-08-26 | 2024-10-04 |  |  |  | 2024-08-26 | 2024-10-04 | 30d | 2024-08-26 | 2024-10-04 | 819d | 0d | start no earlier than 2024-08-26 |  | PP | SI Test | SIT | 5.0 | Heath Thomas | Systems Integration Testing (SIT) | -65.67 | Overdue Start | RED |  |  |  |  |
| 1561 | 1.4.3.4.1.2 | Submit self-declaration to Programme to confirm loading & verification of test data | 30d | 2024-08-26 | 2024-10-04 | 1560SS |  |  | 2024-08-26 | 2024-10-04 | 30d | 2024-08-26 | 2024-10-04 | 819d | 0d |  |  | PP | SI Test | SIT | 5.0 | Heath Thomas | Systems Integration Testing (SIT) | -65.67 | Overdue Start | RED |  |  |  |  |
| 1562 | 1.4.3.4.2 | **E2E Sandbox Participants** | 30d | 2024-08-26 | 2024-10-04 |  |  |  | 2024-08-26 | 2024-10-04 | 30d | 2024-08-26 | 2024-10-04 | 839d |  |  | -0 | N/A | N/A | SIT | 5.0 | N/A | Systems Integration Testing (SIT) |  |  |  |  |  |  |  |
| 1563 | 1.4.3.4.2.1 | UIT environment test data loading and verification (and data cleansing, if required) (for E2E Sandbox Testing Start) | 30d | 2024-08-26 | 2024-10-04 | 1560FF |  |  | 2024-08-26 | 2024-10-04 | 30d | 2024-08-26 | 2024-10-04 | 839d | 0d |  |  | PP | SI Test | SIT | 5.0 | Heath Thomas | Systems Integration Testing (SIT) | -65.67 | Overdue Start | RED |  |  |  |  |
| 1564 | 1.4.3.4.3 | **SI Test Data** | 30d | 2024-08-26 | 2024-10-04 |  |  |  | 2024-08-26 | 2024-10-04 | 30d | 2024-08-26 | 2024-10-04 | 839d |  |  |  | N/A | N/A | SIT | 5.0 | N/A | Systems Integration Testing (SIT) |  |  |  |  |  |  |  |
| 1565 | 1.4.3.4.3.1 | Coordinate Central Parties' UIT environment test data loading and verification (and data cleansing, if required) | 30d | 2024-08-26 | 2024-10-04 | 1560SS |  |  | 2024-08-26 | 2024-10-04 | 30d | 2024-08-26 | 2024-10-04 | 839d |  |  |  | SI Test | PP | SIT | 5.0 | Heath Thomas | Systems Integration Testing (SIT) | -65.67 | Overdue Start | RED |  |  |  |  |
| 1566 | 1.4.3.4.3.2 | Assure evidence of Central Parties' UIT environment test data load and verification | 30d | 2024-08-26 | 2024-10-04 | 1561SS |  |  | 2024-08-26 | 2024-10-04 | 30d | 2024-08-26 | 2024-10-04 | 839d |  |  |  | SI Test | PP | SIT | 5.0 | Heath Thomas | Systems Integration Testing (SIT) | -65.67 | Overdue Start | RED |  |  |  |  |
| 1567 | 1.4.3.4.3.3 | Coordinate E2E Sandbox Participants' UIT environment test data loading and verification (and data cleansing, if required) (for E2E Sandbox Testing Start) | 30d | 2024-08-26 | 2024-10-04 | 1563SS |  |  | 2024-08-26 | 2024-10-04 | 30d | 2024-08-26 | 2024-10-04 | 839d |  |  |  | SI Test | PP | SIT | 5.0 | Heath Thomas | Systems Integration Testing (SIT) | -65.67 | Overdue Start | RED |  |  |  |  |
| 1568 | 1.4.3.5 | **Other Preparation** | 496d | 2022-10-31 A | 2024-09-23 |  | 59% | 201.3d | 2022-10-31 | 2024-09-23 | 484d | 2022-11-16 | 2024-09-23 | 848d |  |  |  | N/A | N/A | SIT | 5.0 | N/A | Systems Integration Testing (SIT) |  |  |  |  |  |  |  |
| 1569 | 1.4.3.5.1 | **SI Other Preparation** | 66d | 2022-10-31 | 2023-01-30 |  |  |  | 2022-10-31 | 2023-01-30 | 66d | 2024-05-02 | 2024-08-01 | 1278d |  |  |  | N/A | N/A | SIT | 5.0 | N/A | Systems Integration Testing (SIT) |  |  |  |  |  |  |  |
| 1570 | 1.4.3.5.1.1 | Onboarding of UIT E2E Sandbox Participants to Test Management Tool for E2E Sandbox Testing Start (onboarding of participants will be ongoing hereafter) | 66d | 2022-10-31 | 2023-01-30 |  |  |  | 2022-10-31 | 2023-01-30 | 66d | 2024-05-02 | 2024-08-01 | 1278d | 393d |  |  | SI Test | PP | SIT | 5.0 | Stuart Scott | Systems Integration Testing (SIT) | -730.67 | Overdue Start | RED |  |  |  |  |
| 1571 | 1.4.3.5.2 | **Other Preparation (for Central Parties & E2E Sandbox Participants)** | 484d | 2022-11-16 A | 2024-09-23 |  | 67% | 161.92d | 2022-11-16 | 2024-09-23 | 484d | 2022-11-16 | 2024-09-23 | 848d |  |  |  | N/A | N/A | SIT | 5.0 | N/A | Systems Integration Testing (SIT) |  |  |  |  |  |  |  |
| 1572 | 1.4.3.5.2.1 | Test Management Tool onboarding for E2E Sandbox Testing Start (onboarding will be ongoing hereafter) | 66d | 2024-05-02 | 2024-08-01 | 1570SS |  |  | 2024-05-02 | 2024-08-01 | 66d | 2024-05-02 | 2024-08-01 | 885d |  | start no earlier than 2024-05-02 |  | PP | SI Test | SIT | 5.0 | Stuart Scott | Systems Integration Testing (SIT) | -181.67 | Overdue Start | RED |  |  |  |  |
| 1573 | 1.4.3.5.2.2 | Other Preparation (incl. test execution planning) | 484d | 2022-11-16 A | 2024-09-23 | 1510SS, 1516SS | 76% | 118d | 2022-11-16 | 2024-09-23 | 484d | 2022-11-16 | 2024-09-23 | 848d |  |  |  | PP | SI Test | SIT | 5.0 | Stuart Scott | Systems Integration Testing (SIT) |  | Overdue | RED |  |  |  |  |
| 1574 | 1.4.3.6 | **UIT E2E Sandbox Test Readiness Report** | 114d | 2024-08-26 | 2025-01-31 |  |  |  | 2024-08-26 | 2025-01-31 | 114d | 2024-08-26 | 2024-10-25 | 750d |  |  | -0 | N/A | N/A | SIT | 5.0 | N/A | Systems Integration Testing (SIT) |  |  |  |  |  |  |  |
| 1575 | 1.4.3.6.1 | **Central Parties E2E Sandbox Test Readiness Report** | 30d | 2024-08-26 | 2024-10-04 |  |  |  | 2024-08-26 | 2024-10-04 | 30d | 2024-08-26 | 2024-10-04 | 819d |  |  |  | N/A | N/A | SIT | 5.0 | N/A | Systems Integration Testing (SIT) |  |  |  |  |  |  |  |
| 1576 | 1.4.3.6.1.1 | Develop draft Test Readiness Report and submit to Programme for assurance | 20d | 2024-08-26 | 2024-09-20 | 1561FF-10d |  |  | 2024-08-26 | 2024-09-20 | 20d | 2024-08-26 | 2024-09-20 | 819d | 0d |  |  | PP | SI Test | SIT | 5.0 | Stuart Scott | Systems Integration Testing (SIT) | -65.67 | Overdue Start | RED |  |  |  |  |
| 1577 | 1.4.3.6.1.2 | Finalise Test Readiness Report and submit to Programme for assurance | 10d | 2024-09-23 | 2024-10-04 | 1561FF |  |  | 2024-09-23 | 2024-10-04 | 10d | 2024-09-23 | 2024-10-04 | 819d | 0d |  |  | PP | SI Test | SIT | 5.0 | Stuart Scott | Systems Integration Testing (SIT) | -37.67 | Overdue Start | RED |  |  |  |  |

Notes:
- 1552: 8/7/24: Updated to reflect the separation between non-sit and s and a and the 4 waves for s and a
- 1553: 8/7/24: Updated to reflect the separation between non-sit and s and a and the 4 waves for s and a
- 1554: 8/7/24: Updated to reflect the separation between non-sit and s and a and the 4 waves for s and a
- 1555: 8/7/24: Updated to reflect the separation between non-sit and s and a and the 4 waves for s and a
- 1560: 1/5: changed from Simon berry to richard puddephatt. Link was 1143(5579) doesnt work now as the date has changed
- 1561: 1/5: changed from Simon berry to richard puddephatt
- 1563: 1/5: changed from Simon berry to richard puddephatt

| ID | WBS | Task | Type | Duration | Start | Finish | Predecessors | Complete | Remaining | Baseline start | Baseline finish | Baseline duration | Baseline 1 start | Baseline 1 finish | Total slack | Free slack | Constraint | Baseline cost | Responsible | Involved | Text9 | Update Version | MHHS Resource Name | MHHS Programme Phase | Task Status | Sched Status | RAG | Artefact ID | Milestone ID | Text29 | Tier | Text3 |
| --- | --- | --- | --- | --- | --- | --- | --- | --- | --- | --- | --- | --- | --- | --- | --- | --- | --- | --- | --- | --- | --- | --- | --- | --- | --- | --- | --- | --- | --- | --- | --- | --- |
| 1578 | 1.4.3.6.2 | **SI E2E Sandbox Test Readiness Report** |  | 40d | 2024-08-26 | 2024-10-18 |  |  |  | 2024-08-26 | 2024-10-18 | 40d | 2024-08-26 | 2024-10-18 | 819d |  |  |  | N/A | N/A | SIT | 5.0 | N/A | Systems Integration Testing (SIT) |  |  |  |  |  |  |  |  |
| 1579 | 1.4.3.6.2.1 | Assure Central Parties' E2E Sandbox Test Readiness Reports |  | 35d | 2024-08-26 | 2024-10-11 | 1576SS, 1577FF+5d |  |  | 2024-08-26 | 2024-10-11 | 35d | 2024-08-26 | 2024-10-11 | 819d | 0d |  |  | SI Test | PP | SIT | 5.0 | Stuart Scott | Systems Integration Testing (SIT) | -65.67 | Overdue Start | RED |  |  |  |  |  |
| 1580 | 1.4.3.6.2.2 | Develop Overarching E2E Sandbox Test Readiness Report |  | 20d | 2024-09-16 | 2024-10-11 | 1579FF |  |  | 2024-09-16 | 2024-10-11 | 20d | 2024-09-16 | 2024-10-11 | 819d | 0d |  |  | SI Test |  | SIT | 5.0 | Stuart Scott | Systems Integration Testing (SIT) | -44.67 | Overdue Start | RED |  |  |  |  |  |
| 1581 | 1.4.3.6.2.3 | Artefact review (via SITAG) and updates |  | 5d | 2024-10-14 | 2024-10-18 | 1580 |  |  | 2024-10-14 | 2024-10-18 | 5d | 2024-10-14 | 2024-10-18 | 819d | 69d |  |  | SI Test | PP,IPA | SIT | 5.0 | Stuart Scott | Systems Integration Testing (SIT) | -16.67 | Overdue Start | RED |  |  |  |  |  |
| 1582 | 1.4.3.6.3 | UIT E2E Sandbox Preparation Complete | milestone | 0d | 2025-01-31 | 2025-01-31 | 1581FS+5d |  |  | 2025-01-31 | 2025-01-31 | 0d | 2024-10-25 | 2024-10-25 | 750d | 1d | start no earlier than 2025-01-31 |  | SI Test | PP | SIT | 5.28 | Stuart Scott | Systems Integration Testing (SIT) | 92.33 | Green | GREEN | MHHS-ART154 MHHS-ART147 | T3-TE-0048 | QAG | T3 |  |
| 1583 | 1.4.4 | **SIT PPs Early Sandbox Testing Execution** |  | 316d | 2025-02-07 | 2026-04-24 |  |  |  | 2025-02-07 | 2026-04-24 | 316d | 2024-11-04 | 2026-01-19 | 434d |  |  | -0 | N/A | N/A | SIT | 5.0 | N/A | Systems Integration Testing (SIT) |  |  |  |  |  |  |  |  |
| 1584 | 1.4.4.1 | SIT PPs E2E Sandbox Testing Start | milestone | 0d | 2025-02-10 | 2025-02-10 | 1582FS+5d |  |  | 2025-02-10 | 2025-02-10 | 0d | 2024-11-04 | 2024-11-04 | 749d | 0d | start no earlier than 2025-02-10 |  | SI Test | PP | SIT | 5.28 | Stuart Scott | Systems Integration Testing (SIT) | 102.33 | Green | GREEN | MHHS-ART018 MHHS-ART154 MHHS-ART147 | T3-TE-0049 | QAG | T3 |  |
| 1585 | 1.4.4.2 | SIT PPs E2E Sandbox Testing Execution |  | 316d | 2025-02-07 | 2026-04-24 | 1584SS-1d |  |  | 2025-02-07 | 2026-04-24 | 316d | 2024-11-04 | 2026-01-19 | 434d |  | start no earlier than 2024-11-04 |  | PP | SI Test | SIT | 5.0 | Stuart Scott | Systems Integration Testing (SIT) | 99.33 | Green | GREEN |  |  |  |  |  |
| 1586 | 1.4.5 | **System Integration Testing - Tier 1 Milestones** |  | 214d? | 2025-02-28 | 2025-12-24 |  |  |  | 2025-02-28 | 2025-12-24 | 0d |  |  | 154d |  |  |  |  |  | SIT |  |  |  | -685.67 | Overdue Start | RED |  |  |  |  |  |
| 1587 | 1.4.5.1 | M10 Checkpoint |  | 1d? | 2025-02-28 | 2025-02-28 | 1588FS-149d |  |  | 2025-02-28 | 2025-02-28 | 0d |  |  | 734d |  |  |  |  |  | SIT | 6.1 |  |  | 120.33 | Green | GREEN |  | T3-MI-0040 |  |  |  |
| 1588 | 1.4.5.2 | Central systems ready for migrating MPANs (M10) | milestone | 0d | 2025-09-24 | 2025-09-24 | 1451FS+20d, 2642, 2399FS+2d, 2396, 2411, 2378, 2382 |  |  | 2025-09-24 | 2025-09-24 | 0d | 2025-03-07 | 2025-03-07 | 5d | 0d | start no earlier than 2025-08-13 |  | CPT | CPT | SIT | 6.1 | CPT | Migration | 328.71 | Green | GREEN |  | T1-MI-1000 | PSG | T1 | Central systems ready for migrating MPANs |
| 1589 | 1.4.5.3 | Central systems ready for migrating MPANs (M10*) - Late Exit | milestone | 0d | 2025-12-24 | 2025-12-24 | 1588FS+65d |  |  | 2025-12-24 | 2025-12-24 | 0d | 2025-06-06 | 2025-06-06 | 521d |  |  |  | CPT | CPT | SIT | 5.0 | CPT | Migration | 419.71 | Green | GREEN |  | T2-MI-1500 | PSG | T1 | Central systems ready for migrating MPANs |
| 1590 | 1.4.6 | **External Programme Dependency Management** |  | 174d | 2022-10-31 A | 2023-06-30 A |  | 100% |  | 2022-10-31 | 2023-06-30 | 174d | 2022-10-31 | 2023-06-30 |  |  |  |  | N/A | N/A | SIT | 5.0 | N/A | Systems Integration Testing (SIT) |  |  |  |  |  |  |  |  |
| 1591 | 1.4.6.1 | **BSC CP1558** |  | 173d | 2022-10-31 A | 2023-06-29 A |  | 100% |  | 2022-10-31 | 2023-06-29 | 173d | 2022-10-31 | 2023-06-29 |  |  |  |  | N/A | N/A | SIT | 5.0 | N/A | Systems Integration Testing (SIT) |  |  |  |  |  |  |  |  |
| 1592 | 1.4.6.1.1 | Monitor progress to implementation date |  | 173d | 2022-10-31 A | 2023-06-28 A |  | 100% |  | 2022-10-31 | 2023-06-28 | 173d | 2022-10-31 | 2023-06-28 |  |  |  |  | CPT | Code Bodies | SIT | 5.0 | Andrew Margan | Systems Integration Testing (SIT) |  | Complete | COMPLETE |  |  |  |  |  |
| 1593 | 1.4.6.1.2 | BSC CP1558 Implementation Date | milestone | 0d | 2023-06-29 A | 2023-06-29 A | 1592 | 100% |  | 2023-06-29 | 2023-06-29 | 0d | 2023-06-29 | 2023-06-29 |  |  | must start on 2023-06-29 |  | Code Bodies |  | SIT | 5.0 | Andrew Margan | Systems Integration Testing (SIT) |  | Complete | COMPLETE |  |  |  |  |  |
| 1594 | 1.4.6.2 | **REC CP R0032** |  | 174d | 2022-10-31 A | 2023-06-30 A |  | 100% |  | 2022-10-31 | 2023-06-30 | 174d | 2022-10-31 | 2023-06-30 |  |  |  |  | N/A | N/A | SIT | 5.0 | N/A | Systems Integration Testing (SIT) |  |  |  |  |  |  |  |  |
| 1595 | 1.4.6.2.1 | Monitor progress to implementation date |  | 174d | 2022-10-31 A | 2023-06-29 A |  | 100% |  | 2022-10-31 | 2023-06-29 | 174d | 2022-10-31 | 2023-06-29 |  |  |  |  | CPT | Code Bodies | SIT | 5.0 | Andrew Margan | Systems Integration Testing (SIT) |  | Complete | COMPLETE |  |  |  |  |  |
| 1596 | 1.4.6.2.2 | REC CP R0032 Implementation Date | milestone | 0d | 2023-06-30 A | 2023-06-30 A | 1595 | 100% |  | 2023-06-30 | 2023-06-30 | 0d | 2023-06-30 | 2023-06-30 |  |  | must start on 2023-06-30 |  | Code Bodies |  | SIT | 5.0 | Andrew Margan | Systems Integration Testing (SIT) |  | Complete | COMPLETE |  |  |  |  |  |
| 1597 | 1.4.6.3 | **REC CP R0044** |  | 173d | 2022-10-31 A | 2023-06-29 A |  | 100% |  | 2022-10-31 | 2023-06-29 | 173d | 2022-10-31 | 2023-06-29 |  |  |  |  | N/A | N/A | SIT | 5.0 | N/A | Systems Integration Testing (SIT) |  |  |  |  |  |  |  |  |
| 1598 | 1.4.6.3.1 | Monitor progress to implementation date |  | 173d | 2022-10-31 A | 2023-06-28 A |  | 100% |  | 2022-10-31 | 2023-06-28 | 173d | 2022-10-31 | 2023-06-28 |  |  |  |  | CPT | Code Bodies | SIT | 5.0 | Andrew Margan | Systems Integration Testing (SIT) |  | Complete | COMPLETE |  |  |  |  |  |
| 1599 | 1.4.6.3.2 | REC CP R0044 Implementation Date | milestone | 0d | 2023-06-29 A | 2023-06-29 A | 1598 | 100% |  | 2023-06-29 | 2023-06-29 | 0d | 2023-06-29 | 2023-06-29 |  |  | must start on 2023-06-29 |  | Code Bodies |  | SIT | 5.0 | Andrew Margan | Systems Integration Testing (SIT) |  | Complete | COMPLETE |  |  |  |  |  |
| 1600 | 1.5 | **NON SIT LDSO QUALIFICATION** |  | 469d? | 2023-11-07 A | 2025-08-22 |  | 65% | 163.76d? | 2023-11-07 | 2025-08-22 | 343d | 2024-01-29 | 2024-07-05 | 609d |  |  | -0 | N/A | N/A | Non-SIT LDSO Qualification |  | N/A | Systems Integration Testing (SIT) |  |  |  |  |  |  |  |  |
| 1601 | 1.5.1 | **Approach Planning** |  | 208d | 2023-11-07 A | 2024-08-22 A |  | 100% |  | 2023-11-07 | 2024-08-22 | 208d |  |  |  |  |  | -0 | N/A | N/A | Non-SIT LDSO Qualification | 5.24 | N/A |  | -386.67 |  |  |  |  |  |  |  |
| 1602 | 1.5.1.1 | Develop Draft Testing Approach & Plan |  | 61d | 2023-11-07 A | 2024-01-30 A |  | 100% |  | 2023-11-07 | 2024-01-30 | 61d |  |  |  |  | start no earlier than 2023-11-07 |  | Non-SIT LDSO | Non-SIT LDSO | Non-SIT LDSO Qualification | 5.24 | Ben Wickins |  |  | Complete | COMPLETE |  |  |  |  |  |
| 1603 | 1.5.1.2 | Draft Testing Approach & Plan Issued to LDSO for Review |  | 1d | 2024-01-31 A | 2024-01-31 A | 1602 | 100% |  | 2024-01-31 | 2024-01-31 | 1d |  |  |  |  |  |  | Non-SIT LDSO | Non-SIT LDSO | Non-SIT LDSO Qualification | 5.24 | Ben Wickins |  |  | Complete | COMPLETE |  |  |  |  |  |
| 1604 | 1.5.1.3 | LDSO Review Complete |  | 10d | 2024-02-01 A | 2024-02-14 A | 1603 | 100% |  | 2024-02-01 | 2024-02-14 | 10d |  |  |  |  |  |  | LDSOs | Non-SIT LDSO | Non-SIT LDSO Qualification | 5.24 | Ben Wickins |  |  | Complete | COMPLETE |  |  |  |  |  |
| 1605 | 1.5.1.4 | Update Following LDSO Review |  | 14d | 2024-02-15 A | 2024-03-05 A | 1604 | 100% |  | 2024-02-15 | 2024-03-05 | 14d |  |  |  |  |  |  | Non-SIT LDSO | Non-SIT LDSO, Code Bodies | Non-SIT LDSO Qualification | 5.24 | Ben Wickins |  |  | Complete | COMPLETE |  |  |  |  |  |
| 1606 | 1.5.1.5 | QWG Review of Approach & Plan |  | 1d | 2024-03-12 A | 2024-03-12 A | 1605FS+4d | 100% |  | 2024-03-12 | 2024-03-12 | 1d |  |  |  |  |  |  | Non-SIT LDSO, PP | Non-SIT LDSO, Code Bodies | Non-SIT LDSO Qualification | 5.24 | Ben Wickins |  |  | Complete | COMPLETE |  |  |  |  |  |
| 1607 | 1.5.1.6 | QAG Approval for Approach & Plan | milestone | 0d | 2024-03-21 A | 2024-03-21 A | 1606FS+7d | 100% |  | 2024-03-21 | 2024-03-21 | 0d |  |  |  |  |  |  | Code Bodies | Non-SIT LDSO,Code Bodies | Non-SIT LDSO Qualification | 5.24 | Ben Wickins |  |  | Complete | COMPLETE |  |  |  |  |  |
| 1608 | 1.5.1.7 | Confirmation of Participants for Non-SIT LDSO Qualification Testing | milestone | 0d | 2024-03-21 A | 2024-03-21 A | 1607 | 100% |  | 2024-03-21 | 2024-03-21 | 0d | 2024-01-29 | 2024-01-29 |  |  |  |  | Non-SIT LDSO | SI Test, PP, IPA | Non-SIT LDSO Qualification | 5.24 | Ben Wickins | Systems Integration Testing (SIT) |  | Complete | COMPLETE |  | T3-QU-0011 | QAG (Non-SIT LDSO) | T3 |  |
| 1609 | 1.5.1.8 | Update to Annex 1 for internal review (NF, Not Operational) |  | 15d | 2024-03-18 A | 2024-04-05 A | 1073 | 100% |  | 2024-03-18 | 2024-04-05 | 15d |  |  |  |  |  |  | Non-SIT LDSO | PP, Code Bodies | Non-SIT LDSO Qualification | 5.24 | Ben Wickins |  |  | Complete | COMPLETE |  |  |  |  |  |
| 1610 | 1.5.1.9 | Non-Functional, Operational & Migration Approaches Socialised with Code Bodies & LDSO & Feedback Actioned |  | 86d | 2024-04-08 A | 2024-08-05 A | 1609 | 100% |  | 2024-04-08 | 2024-08-05 | 86d |  |  |  |  |  |  | Non-SIT LDSO | PP, Code Bodies | Non-SIT LDSO Qualification | 5.27 | Ben Wickins |  |  | Complete | COMPLETE |  |  |  |  |  |
| 1611 | 1.5.1.10 | QWG Review Operational, Non-Functional & Migration Annexes of Approach & Plan |  | 1d | 2024-08-13 A | 2024-08-13 A | 1610FS+5d | 100% |  | 2024-08-13 | 2024-08-13 | 1d |  |  |  |  |  |  | Non-SIT LDSO, PP | Non-SIT LDSO, PP, Code Bodies | Non-SIT LDSO Qualification | 5.27 | Ben Wickins |  |  | Complete | COMPLETE |  |  |  |  |  |
| 1612 | 1.5.1.11 | Update Following QWG Review |  | 6d | 2024-08-14 A | 2024-08-21 A | 1611 | 100% |  | 2024-08-14 | 2024-08-21 | 6d |  |  |  |  |  |  | Non-SIT LDSO, PP | Non-SIT LDSO, Code Bodies | Non-SIT LDSO Qualification | 5.27 | Ben Wickins |  |  | Complete | COMPLETE |  |  |  |  |  |
| 1613 | 1.5.1.12 | QAG Approval for Operational, Non-Functional & Migration Annexes of Approach & Plan | milestone | 0d | 2024-08-22 A | 2024-08-22 A | 1612FS+1d, 1608, 1076 | 100% |  | 2024-08-22 | 2024-08-22 | 0d |  |  |  |  |  |  | Code Bodies | Non-SIT LDSO, Code Bodies | Non-SIT LDSO Qualification | 5.29 | Ben Wickins |  |  | Complete | COMPLETE |  | T3-QU-0110 | QAG (Non-SIT LDSO) |  |  |

Notes:
- 1582: 11/7/24: Date change approved at QAG on 20/6/24 from 25/10/24 to 31/1/25
- 1584: 11/7/24: Date change approved at QAG on 20/6/24 from 4/11/24 to 10/2/25
- 1588: 16/09/24 - Date updated to 13/08/25 in line with recalibration exercise.
- 1609: Guidance: 26/3: Linked to the development of SIT non functional plan
- 1613: Guidance: 18/7/24: Date change from 18/7/24 to 22/8/24 approved at QAG on 18/7/24

| ID | WBS | Task | Type | Duration | Start | Finish | Predecessors | Complete | Remaining | Baseline start | Baseline finish | Baseline duration | Baseline 1 start | Baseline 1 finish | Total slack | Constraint | Baseline cost | Responsible | Involved | Text9 | Task Status | Update Version | MHHS Resource Name | Sched Status | RAG | Milestone ID | Text29 | MHHS Programme Phase | Tier |
| --- | --- | --- | --- | --- | --- | --- | --- | --- | --- | --- | --- | --- | --- | --- | --- | --- | --- | --- | --- | --- | --- | --- | --- | --- | --- | --- | --- | --- | --- |
| 1614 | 1.5.2 | **Functional Test Cases & Scenarios** |  | 58d | 2024-01-30 A | 2024-04-18 A |  | 100% |  | 2024-01-30 | 2024-04-18 | 58d |  |  |  |  | -0 | N/A | N/A | Non-SIT LDSO Qualification | -385.67 | 5.24 | N/A |  |  |  |  |  |  |
| 1615 | 1.5.2.1 | **Functional Test Cases & Scenarios Batch 1** |  | 8d | 2024-01-30 A | 2024-02-08 A |  | 100% |  | 2024-01-30 | 2024-02-08 | 8d |  |  |  |  | -0 | N/A | N/A | Non-SIT LDSO Qualification |  | 5.24 | N/A |  |  |  |  |  |  |
| 1616 | 1.5.2.1.1 | Walkthrough Test Cases & Scenarios Batch 1 with Code Bodies |  | 1d | 2024-01-30 A | 2024-01-30 A | 1602SS+60d | 100% |  | 2024-01-30 | 2024-01-30 | 1d |  |  |  |  |  | Non-SIT LDSO | Non-SIT LDSO, Code Bodies | Non-SIT LDSO Qualification |  | 5.24 | Ben Wickins | Complete | COMPLETE |  |  |  |  |
| 1617 | 1.5.2.1.2 | Walkthrough Test Cases & Scenarios Batch 1 with LDSO |  | 1d | 2024-02-01 A | 2024-02-01 A | 1616 | 100% |  | 2024-02-01 | 2024-02-01 | 1d |  |  |  |  |  | LDSO, Non-SIT LDSO | LDSO, Non-SIT LDSO | Non-SIT LDSO Qualification |  | 5.24 | Ben Wickins | Complete | COMPLETE |  |  |  |  |
| 1618 | 1.5.2.1.3 | Action Feedback on Test Cases & Scenarios Batch 1 |  | 5d | 2024-02-02 A | 2024-02-08 A | 1617 | 100% |  | 2024-02-02 | 2024-02-08 | 5d |  |  |  |  |  | Non-SIT LDSO | Non-SIT LDSO, LDSO , Code Bodies | Non-SIT LDSO Qualification |  | 5.24 | Ben Wickins | Complete | COMPLETE |  |  |  |  |
| 1619 | 1.5.2.2 | **Functional Test Cases & Scenarios Batch 2** |  | 14d | 2024-02-20 A | 2024-03-08 A |  | 100% |  | 2024-02-20 | 2024-03-08 | 14d |  |  |  |  | -0 | N/A | N/A | Non-SIT LDSO Qualification |  | 5.24 | N/A |  |  |  |  |  |  |
| 1620 | 1.5.2.2.1 | Walkthrough Test Cases & Scenarios Batch 2 with Code Bodies |  | 1d | 2024-02-20 A | 2024-02-20 A | 1602SS+75d | 100% |  | 2024-02-20 | 2024-02-20 | 1d |  |  |  |  |  | Non-SIT LDSO | Non-SIT LDSO, Code Bodies | Non-SIT LDSO Qualification |  | 5.24 | Ben Wickins | Complete | COMPLETE |  |  |  |  |
| 1621 | 1.5.2.2.2 | Walkthrough Test Cases & Scenarios Batch 2 with LDSO |  | 1d | 2024-03-01 A | 2024-03-01 A | 1620FS+7d | 100% |  | 2024-03-01 | 2024-03-01 | 1d |  |  |  |  |  | LDSO, Non-SIT LDSO | LDSO, Non-SIT LDSO | Non-SIT LDSO Qualification |  | 5.24 | Ben Wickins | Complete | COMPLETE |  |  |  |  |
| 1622 | 1.5.2.2.3 | Action Feedback on Test Cases & Scenarios Batch 2 |  | 5d | 2024-03-04 A | 2024-03-08 A | 1621 | 100% |  | 2024-03-04 | 2024-03-08 | 5d |  |  |  |  |  | Non-SIT LDSO | Non-SIT LDSO, LDSO , Code Bodies | Non-SIT LDSO Qualification |  | 5.24 | Ben Wickins | Complete | COMPLETE |  |  |  |  |
| 1623 | 1.5.2.3 | **Functional Test Cases & Scenarios Batch 3** |  | 13d | 2024-03-20 A | 2024-04-05 A |  | 100% |  | 2024-03-20 | 2024-04-05 | 13d |  |  |  |  | -0 | N/A | N/A | Non-SIT LDSO Qualification |  | 5.24 | N/A |  |  |  |  |  |  |
| 1624 | 1.5.2.3.1 | Walkthrough Test Cases & Scenarios Batch 3 with Code Bodies |  | 1d | 2024-03-20 A | 2024-03-20 A | 1602SS+96d | 100% |  | 2024-03-20 | 2024-03-20 | 1d |  |  |  |  |  | Non-SIT LDSO | Non-SIT LDSO, Code Bodies | Non-SIT LDSO Qualification |  | 5.24 | Ben Wickins | Complete | COMPLETE |  |  |  |  |
| 1625 | 1.5.2.3.2 | Walkthrough Test Cases & Scenarios Batch 3 with LDSO |  | 1d | 2024-03-28 A | 2024-03-28 A | 1624FS+5d | 100% |  | 2024-03-28 | 2024-03-28 | 1d |  |  |  |  |  | LDSO, Non-SIT LDSO | LDSO, Non-SIT LDSO | Non-SIT LDSO Qualification |  | 5.24 | Ben Wickins | Complete | COMPLETE |  |  |  |  |
| 1626 | 1.5.2.3.3 | Action Feedback on Test Cases & Scenarios Batch 3 |  | 6d | 2024-03-29 A | 2024-04-05 A | 1625 | 100% |  | 2024-03-29 | 2024-04-05 | 6d |  |  |  |  |  | Non-SIT LDSO | Non-SIT LDSO, LDSO , Code Bodies | Non-SIT LDSO Qualification |  | 5.24 | Ben Wickins | Complete | COMPLETE |  |  |  |  |
| 1627 | 1.5.2.4 | Test Cases & Scenarios Batch 1-3 Discussion at QWG |  | 1d | 2024-04-09 A | 2024-04-09 A | 1618, 1622, 1626FS+1d | 100% |  | 2024-04-09 | 2024-04-09 | 1d |  |  |  |  |  | Non-SIT LDSO, PP | Non-SIT LDSO, Code Bodies | Non-SIT LDSO Qualification |  | 5.24 | Ben Wickins | Complete | COMPLETE |  |  |  |  |
| 1628 | 1.5.2.5 | Action QWG Feedback on Test Cases & Scenarios Batch 1-3 |  | 2d | 2024-04-10 A | 2024-04-11 A | 1627 | 100% |  | 2024-04-10 | 2024-04-11 | 2d |  |  |  |  |  | Non-SIT LDSO | Non-SIT LDSO, Code Bodies | Non-SIT LDSO Qualification |  | 5.24 | Ben Wickins | Complete | COMPLETE |  |  |  |  |
| 1629 | 1.5.2.6 | Batch 1-3 Non-SIT LDSO QT Functional Test Scenarios and Test Cases approved | milestone | 0d | 2024-04-18 A | 2024-04-18 A | 1628FS+5d | 100% |  | 2024-04-18 | 2024-04-18 | 0d |  |  |  |  |  | Code Bodies | Non-SIT LDSO, Code Bodies | Non-SIT LDSO Qualification |  | 5.24 | Ben Wickins | Complete | COMPLETE | T3-QU-0069 | QAG (Non-SIT LDSO) |  |  |
| 1630 | 1.5.3 | **Test Execution Schedule** |  | 161d | 2024-04-19 A | 2024-11-29 |  | 99% | 0d | 2024-04-19 | 2024-11-29 | 90d | 2024-01-29 | 2024-04-26 | 799d |  | -0 | N/A | N/A | Non-SIT LDSO Qualification |  | 5.24 | N/A |  |  |  |  | Systems Integration Testing (SIT) |  |
| 1631 | 1.5.3.1 | Draft Test Delivery Schedule for Functional and Operational Testing |  | 20d | 2024-04-19 A | 2024-05-16 A | 1629 | 100% |  | 2024-04-19 | 2024-05-16 | 20d | 2024-01-29 | 2024-03-22 |  |  |  | Non-SIT LDSO | SI Test, PP, Non-SIT LDSO | Non-SIT LDSO Qualification |  | 5.24 | Ben Wickins | Complete | COMPLETE |  |  | Systems Integration Testing (SIT) |  |
| 1632 | 1.5.3.2 | Socialise Test Delivery Schedule with Code Bodies & LDSO for Review & Action Feedback |  | 37d | 2024-05-17 A | 2024-07-08 A | 1631 | 100% |  | 2024-05-17 | 2024-07-08 | 37d |  |  |  |  |  | Non-SIT LDSO | LDSO, Code Bodies, Non-SIT LDSO | Non-SIT LDSO Qualification |  | 5.24 | Ben Wickins | Complete | COMPLETE |  |  |  |  |
| 1633 | 1.5.3.3 | Agree Test Execution Timetable Format at QWG, Including Anonymisation Requirements |  | 1d | 2024-07-09 A | 2024-07-09 A | 1632 | 100% |  | 2024-07-09 | 2024-07-09 | 1d | 2024-03-25 | 2024-04-19 |  |  |  | Non-SIT LDSO, PP | Non-SIT LDSO, Code Bodies | Non-SIT LDSO Qualification |  | 5.24 | Ben Wickins | Complete | COMPLETE |  |  | Systems Integration Testing (SIT) |  |
| 1634 | 1.5.3.4 | Action QWG Feedback |  | 3d | 2024-07-10 A | 2024-07-12 A | 1633 | 100% |  | 2024-07-10 | 2024-07-12 | 3d |  |  |  |  |  | Non-SIT LDSO, PP | Non-SIT LDSO, Code Bodies | Non-SIT LDSO Qualification |  | 5.24 | Ben Wickins | Complete | COMPLETE |  |  |  |  |
| 1635 | 1.5.3.5 | Agree Test Execution Timetable Format at QAG, Including Anonymisation Requirements | milestone | 0d | 2024-07-18 A | 2024-07-18 A | 1634FS+4d | 100% |  | 2024-07-18 | 2024-07-18 | 0d |  |  |  |  |  | Code Bodies | Non-SIT LDSO, Code Bodies | Non-SIT LDSO Qualification |  | 5.29 | Ben Wickins | Complete | COMPLETE | T3-QU-0111 | QAG (Non-SIT LDSO) |  |  |
| 1636 | 1.5.3.6 | Qualification Testing for Non-SIT LDSOs (Functional, Migration, NFT, Operational) Test Execution Schedule Complete | milestone | 0d | 2024-11-29 | 2024-11-29 | 1613 |  |  | 2024-11-29 | 2024-11-29 | 0d | 2024-04-26 | 2024-04-26 | 799d | finish no earlier than 2024-11-29 |  | Non-SIT LDSO | Non-SIT LDSO, Code Bodies, PP | Non-SIT LDSO Qualification | 29.71 | 5.29 | Ben Wickins | Green | GREEN | T3-QU-0008 | QAG (Non-SIT LDSO) | Systems Integration Testing (SIT) | T3 |
| 1637 | 1.5.4 | **Functional, Non-Functional, Operational & Migration Test Scenarios & Cases** |  | 110d | 2024-03-22 A | 2024-08-22 A |  | 100% |  | 2024-03-22 | 2024-08-22 | 110d |  |  |  |  | -0 | N/A | N/A | Non-SIT LDSO Qualification |  | 5.24 | N/A |  |  |  |  |  |  |
| 1638 | 1.5.4.1 | Test Scenarios & Cases - Functional - Drafted, Reviewed |  | 14d | 2024-04-01 A | 2024-04-18 A | 1607 | 100% |  | 2024-04-01 | 2024-04-18 | 14d |  |  |  |  |  | Non-SIT LDSO | Non-SIT LDSO, LDSO, Code Bodies | Non-SIT LDSO Qualification |  | 5.24 | Ben Wickins | Complete | COMPLETE |  |  |  |  |
| 1639 | 1.5.4.2 | Test Scenarios & Cases- Functional - Approved at QAG | milestone | 0d | 2024-04-18 A | 2024-04-18 A | 1638 | 100% |  | 2024-04-18 | 2024-04-18 | 0d |  |  |  |  |  | Non-SIT LDSO | Non-SIT LDSO, LDSO, Code Bodies | Non-SIT LDSO Qualification |  | 5.24 | Ben Wickins | Complete | COMPLETE | T3-QU-0070 | QAG (Non-SIT LDSO) |  |  |
| 1640 | 1.5.4.3 | Test Scenarios & Cases - Non-Functional - Drafted, Reviewed |  | 110d | 2024-03-22 A | 2024-08-22 A | 1607, 1093FF | 100% |  | 2024-03-22 | 2024-08-22 | 110d |  |  |  |  |  | Non-SIT LDSO | Non-SIT LDSO, LDSO, Code Bodies | Non-SIT LDSO Qualification |  | 5.24 | Ben Wickins | Complete | COMPLETE |  |  |  |  |
| 1641 | 1.5.4.4 | Test Scenarios & Cases - Non-Functional - Approved at QAG | milestone | 0d | 2024-08-22 A | 2024-08-22 A | 1640 | 100% |  | 2024-08-22 | 2024-08-22 | 0d |  |  |  |  |  | Non-SIT LDSO | Non-SIT LDSO, LDSO, Code Bodies | Non-SIT LDSO Qualification |  | 5.29 | Ben Wickins | Complete | COMPLETE | T3-QU-0071 | QAG (Non-SIT LDSO) |  |  |
| 1642 | 1.5.4.5 | Test Scenarios & Cases - Migration - Drafted, Reviewed |  | 45d | 2024-03-22 A | 2024-05-23 A | 1607 | 100% |  | 2024-03-22 | 2024-05-23 | 45d |  |  |  |  |  | Non-SIT LDSO | Non-SIT LDSO, LDSO, Code Bodies | Non-SIT LDSO Qualification |  | 5.24 | Ben Wickins | Complete | COMPLETE |  |  |  |  |
| 1643 | 1.5.4.6 | Test Scenarios & Cases - Migration - Approved at QAG | milestone | 0d | 2024-05-23 A | 2024-05-23 A | 1642 | 100% |  | 2024-05-23 | 2024-05-23 | 0d |  |  |  |  |  | Non-SIT LDSO | Non-SIT LDSO, LDSO, Code Bodies | Non-SIT LDSO Qualification |  | 5.24 | Ben Wickins | Complete | COMPLETE | T3-QU-0072 | QAG (Non-SIT LDSO) |  |  |
| 1644 | 1.5.4.7 | Test Scenarios & Cases - Operational - Drafted, Reviewed |  | 59d | 2024-06-03 A | 2024-08-22 A | 1607FS+51d | 100% |  | 2024-06-03 | 2024-08-22 | 59d |  |  |  |  |  | Non-SIT LDSO | Non-SIT LDSO, LDSO, Code Bodies | Non-SIT LDSO Qualification |  | 5.24 | Ben Wickins | Complete | COMPLETE |  |  |  |  |
| 1645 | 1.5.4.8 | Test Scenarios & Cases - Operational - Approved at QAG | milestone | 0d | 2024-08-22 A | 2024-08-22 A | 1644, 1093FF | 100% |  | 2024-08-22 | 2024-08-22 | 0d |  |  |  |  |  | Non-SIT LDSO | Non-SIT LDSO, LDSO, Code Bodies | Non-SIT LDSO Qualification |  | 5.29 | Ben Wickins | Complete | COMPLETE | T3-QU-0073 | QAG (Non-SIT LDSO) |  |  |

Notes:
- 1636: Date not met because of re-planning activity around SIT Cycle 2 Maintenance window. Maintain dialog with Programme scenario planning from SIT. New forecast date will be defined after programme scenario CR is approved, expected to be 29th November. / Guidance: 18/7/24: Date change from 15/8/24 to 22/8/24 approved at QAG on 18/7/24
- 1641: Guidance: 18/7/24: Date change from 18/7/24 to 22/8/24 approved at QAG on 18/7/24
- 1645: Guidance: 18/7/24: Date change from 18/7/24 to 22/8/24 approved at QAG on 18/7/24

| ID | WBS | Task | Type | Duration | Start | Finish | Predecessors | Complete | Remaining | Baseline start | Baseline finish | Baseline duration | Total slack | Free slack | Constraint | Deadline | Baseline cost | Responsible | Involved | Text9 | Task Status | Update Version | MHHS Resource Name | Sched Status | RAG | Milestone ID | Text29 |
| --- | --- | --- | --- | --- | --- | --- | --- | --- | --- | --- | --- | --- | --- | --- | --- | --- | --- | --- | --- | --- | --- | --- | --- | --- | --- | --- | --- |
| 1646 | 1.5.5 | **Test Data** |  | 345d | 2024-01-22 A | 2025-05-16 |  | 44% | 194.37d | 2024-01-22 | 2025-05-16 | 241d | 679d |  |  |  | -0 | N/A | N/A | Non-SIT LDSO Qualification | -385.67 | 5.24 | N/A |  |  |  |  |
| 1647 | 1.5.5.1 | Test Data Plan Drafted & Reviewed |  | 89d | 2024-01-22 A | 2024-05-23 A | 1602 | 100% |  | 2024-01-22 | 2024-05-23 | 89d |  |  |  |  |  | Code Bodies | Non-SIT LDSO, Code Bodies | Non-SIT LDSO Qualification |  | 5.24 | Ben Wickins | Complete | COMPLETE |  |  |
| 1648 | 1.5.5.2 | Non-SIT LDSO QT Test Data Plan Approved by QAG | milestone | 0d | 2024-05-23 A | 2024-05-23 A | 1647 | 100% |  | 2024-05-23 | 2024-05-23 | 0d |  |  |  |  |  | Code Bodies | Non-SIT LDSO, Code Bodies | Non-SIT LDSO Qualification |  | 5.24 | Ben Wickins | Complete | COMPLETE | T3-QU-0074 | QAG (Non-SIT LDSO) |
| 1649 | 1.5.5.3 | Develop Test Data Matrices |  | 10d | 2024-05-24 A | 2024-06-06 A | 1648 | 100% |  | 2024-05-24 | 2024-06-06 | 10d |  |  |  |  |  | Non-SIT LDSO | Non-SIT LDSO | Non-SIT LDSO Qualification |  | 5.24 | Ben Wickins | Complete | COMPLETE |  |  |
| 1650 | 1.5.5.4 | Test Data Cut |  | 17d | 2024-05-24 A | 2024-06-17 A | 1648 | 100% |  | 2024-05-24 | 2024-06-17 | 17d |  |  |  |  |  | PP, Non-SIT LDSO | PP, Non-SIT LDSO | Non-SIT LDSO Qualification |  | 5.24 | Ben Wickins | Complete | COMPLETE |  |  |
| 1651 | 1.5.5.5 | Test Data Cut Complete | milestone | 0d | 2024-06-17 A | 2024-06-17 A | 1650, 1649 | 100% |  | 2024-06-17 | 2024-06-17 | 0d |  |  |  |  |  | PP, Non-SIT LDSO | PP, Non-SIT LDSO | Non-SIT LDSO Qualification |  | 5.27 | Ben Wickins | Complete | COMPLETE | T3-QU-0112 | QAG (Non-SIT LDSO) |
| 1652 | 1.5.5.6 | Test Data Reviewed by the Programme |  | 39d | 2024-06-18 A | 2024-08-09 A | 1651 | 100% |  | 2024-06-18 | 2024-08-09 | 39d |  |  |  |  |  | Non-SIT LDSO | PP, Non-SIT LDSO | Non-SIT LDSO Qualification |  | 5.24 | Ben Wickins | Complete | COMPLETE |  |  |
| 1653 | 1.5.5.7 | Test Data Loaded |  | 85d | 2024-08-12 | 2024-12-06 | 1652 |  |  | 2024-08-12 | 2024-12-06 | 17d | 679d | 0d |  |  |  | Non-SIT LDSO | PP, Non-SIT LDSO | Non-SIT LDSO Qualification | -79.67 | 5.24 | Ben Wickins | Overdue Start | GREEN |  |  |
| 1654 | 1.5.5.8 | Test Data Signed Off | milestone | 0d | 2024-12-06 | 2024-12-06 | 1653 |  |  | 2024-12-06 | 2024-12-06 | 0d | 679d | 0d |  |  |  | Non-SIT LDSO | PP, Non-SIT LDSO | Non-SIT LDSO Qualification | 36.71 | 5.25 | Ben Wickins | Green | GREEN | T3-QU-0113 | QAG (Non-SIT LDSO) |
| 1655 | 1.5.5.9 | Test Execution Data Support |  | 115d | 2024-12-09 | 2025-05-16 | 1654 |  |  | 2024-12-09 | 2025-05-16 | 79d | 679d |  |  |  |  | Non-SIT LDSO | Non-SIT LDSO | Non-SIT LDSO Qualification | 39.33 | 5.24 | Ben Wickins | Green | GREEN |  |  |
| 1656 | 1.5.6 | **Tooling** |  | 148d | 2024-01-31 A | 2024-08-23 A |  | 100% |  | 2024-01-31 | 2024-08-23 | 148d |  |  |  |  | -0 | N/A | N/A | Non-SIT LDSO Qualification | -385.67 | 5.24 | N/A |  |  |  |  |
| 1657 | 1.5.6.1 | Design Approach & Set-Up ADO Tool for Test & Defect Management Tool |  | 53d | 2024-01-31 A | 2024-04-12 A | 1602 | 100% |  | 2024-01-31 | 2024-04-12 | 53d |  |  |  |  |  | Non-SIT LDSO | Non-SIT LDSO, SI Test | Non-SIT LDSO Qualification |  | 5.24 | Ben Wickins | Complete | COMPLETE |  |  |
| 1658 | 1.5.6.2 | Develop Training Requirements & Materials Inc. Day in the Life |  | 87d | 2024-04-15 A | 2024-08-13 A | 1657 | 100% |  | 2024-04-15 | 2024-08-13 | 87d |  |  |  |  |  | Non-SIT LDSO | Non-SIT LDSO, SI Test | Non-SIT LDSO Qualification |  | 5.24 | Ben Wickins | Complete | COMPLETE |  |  |
| 1659 | 1.5.6.3 | ADO Launch complete |  | 1d | 2024-08-23 A | 2024-08-23 A | 1658, 1639, 1643, 1645 | 100% |  | 2024-08-23 | 2024-08-23 | 1d |  |  |  |  |  | Non-SIT LDSO | Non-SIT LDSO | Non-SIT LDSO Qualification |  | 5.24 | Ben Wickins | Complete | COMPLETE |  |  |
| 1660 | 1.5.7 | **Pre-Integration Testing** |  | 258d | 2024-01-31 A | 2025-01-24 |  | 76% | 61.54d | 2024-01-31 | 2024-11-29 | 174d | 759d |  |  |  | -0 | N/A | N/A | Non-SIT LDSO Qualification | -385.67 | 5.24 | N/A |  |  |  |  |
| 1661 | 1.5.7.1 | PIT Guidance & Templates & Approach & Plans Developed |  | 106d | 2024-02-05 A | 2024-07-01 A | 1602FS+3d | 100% |  | 2024-02-05 | 2024-07-01 | 106d |  |  |  |  |  | Non-SIT LDSO | Non-SIT LDSO, LDSO | Non-SIT LDSO Qualification |  | 5.27 | Ben Wickins | Complete | COMPLETE |  |  |
| 1662 | 1.5.7.2 | PIT Test Approach & Plan Deadline for Submission for Non-SIT LDSO​ QT | milestone | 0d | 2024-07-01 A | 2024-07-01 A | 1661 | 100% |  | 2024-07-01 | 2024-07-01 | 0d |  |  |  |  |  | Non-SIT LDSO | Non-SIT LDSO, LDSO | Non-SIT LDSO Qualification |  | 5.28 | Ben Wickins | Complete | COMPLETE | T3-QU-0075 | QAG (Non-SIT LDSO) |
| 1663 | 1.5.7.3 | Develop and agree PIT Test Scenarios |  | 20d | 2024-07-02 A | 2024-07-29 A | 1662 | 100% |  | 2024-07-02 | 2024-07-29 | 31d |  |  |  |  |  | Non-SIT LDSO | Non-SIT LDSO, Code Bodies, LDSO | Non-SIT LDSO Qualification |  | 5.24 | Ben Wickins | Complete | COMPLETE |  |  |
| 1664 | 1.5.7.4 | PIT Execution (Functional and Migration) | manual | 45d | 2024-09-30 A | 2024-11-29 | 1663 | 16% | 38d | 2024-09-30 | 2024-11-29 | 45d |  |  | start no earlier than 2024-09-30 |  |  | Non-SIT LDSO | Non-SIT LDSO, LDSO | Non-SIT LDSO Qualification |  | 5.24 | Ben Wickins | Green | GREEN |  |  |
| 1665 | 1.5.7.5 | PIT Execution (Non-Functional and Operational) |  | 90d | 2024-09-23 A | 2025-01-24 | 1663 | 21% | 71d | 2024-09-23 | 2025-01-24 | 0d | 112d | 0d |  |  |  |  |  | Non-SIT LDSO Qualification |  |  |  | Green | GREEN |  |  |
| 1666 | 1.5.7.6 | Non-SIT LDSO Participants have submitted functional PIT Test Completion Report & evidence for QT Entry​ | milestone | 0d | 2024-11-29 | 2024-11-29 | 1664 |  |  | 2024-11-29 | 2024-11-29 | 0d | 799d | 15d |  |  |  | Non-SIT LDSO | Non-SIT LDSO, LDSO | Non-SIT LDSO Qualification | 29.71 | 5.24 | Ben Wickins | Green | GREEN | T3-QU-0076 | QAG (Non-SIT LDSO) |
| 1667 | 1.5.7.7 | Non-SIT LDSO Participants have submitted non-functional PIT Test Completion Report | milestone | 0d | 2025-01-24 | 2025-01-24 | 1665 |  |  | 2025-01-27 | 2025-01-27 | 0d | 112d | 60d |  |  |  |  |  | Non-SIT LDSO Qualification | 85.71 |  |  | Green | GREEN |  |  |
| 1668 | 1.5.7.8 | **Placing Reliance - Code Body & LDSO Functional and Migration** |  | 147d | 2024-01-31 A | 2024-08-22 A |  | 100% |  | 2024-01-31 | 2024-08-22 | 147d |  |  |  |  | -0 | N/A | N/A | Non-SIT LDSO Qualification | -100.67 | 5.24 | N/A |  |  |  |  |
| 1669 | 1.5.7.8.1 | Placing Reliance Submitted & Reviewed |  | 21d | 2024-01-31 A | 2024-02-28 A | 1602 | 100% |  | 2024-01-31 | 2024-02-28 | 21d |  |  |  | 2024-01-05 |  | LDSO, Non-SIT LDSO | LDSO, Non-SIT LDSO | Non-SIT LDSO Qualification |  | 5.24 | Ben Wickins | Complete | COMPLETE |  |  |
| 1670 | 1.5.7.8.2 | Define & Agree QT Testing for Each LDSO |  | 22d | 2024-02-29 A | 2024-03-29 A | 1669 | 100% |  | 2024-02-29 | 2024-03-29 | 22d |  |  |  |  |  | Non-SIT LDSO | LDSO, Non-SIT LDSO | Non-SIT LDSO Qualification |  | 5.24 | Ben Wickins | Complete | COMPLETE |  |  |
| 1671 | 1.5.7.8.3 | Develop Test Scope & Reliance Submissions |  | 20d | 2024-04-01 A | 2024-04-26 A | 1670 | 100% |  | 2024-04-01 | 2024-04-26 | 20d |  |  |  |  |  | Non-SIT LDSO | LDSO, Non-SIT LDSO, Code Bodies | Non-SIT LDSO Qualification |  | 5.24 | Ben Wickins | Complete | COMPLETE |  |  |
| 1672 | 1.5.7.8.4 | Review and Consultation |  | 84d | 2024-04-29 A | 2024-08-22 A | 1671, 1613FF | 100% |  | 2024-04-29 | 2024-08-22 | 84d |  |  |  |  |  | Non-SIT LDSO | LDSO, Non-SIT LDSO | Non-SIT LDSO Qualification |  | 5.27 | Ben Wickins | Complete | COMPLETE |  |  |

Notes:
- 1654: Date will be missed due to QT execution replanning. Additionally, the Test Harness will be loaded with dummy suppliers MHHS (outgoing supplier) and MHHX (incoming supplier) for the Change of Supply Test Cases. For messages to flow between DIP, the LDSO systems and the Test Harness the LDSO systems need to be updated with these dummy suppliers. Test data was submitted by LDSOs and team is currently reviewing and filling gaps. Once this is complete, LDSOs can upload to SFTP. Forecast finish date is 06/12/24. / Notes (2): LDSOs will not be able to meet the standards of M10 and achieve Qualification. Through QWG and the LQTSG we have proposed and are discussing solutions with the LDSOs, with a view to achieving full test coverage for all
- 1662: 13/5: New milestone approved as part of cr47. 11/6: Missed date because additional time requested by PPs. 24/6: Approved at QAG on 20/6
- 1665: 21/10/24 - Proposed to add this as a new activity, to go to QAG for approval.
- 1666: On track.
- 1667: 21/10/24 - Proposed to add this as a new activity, to go to QAG for approval.

| ID | WBS | Task | Type | Duration | Start | Finish | Predecessors | Complete | Remaining | Baseline start | Baseline finish | Baseline duration | Baseline 1 start | Baseline 1 finish | Total slack | Free slack | Constraint | Baseline cost | Responsible | Involved | Text9 | Task Status | Update Version | MHHS Resource Name | Sched Status | RAG | Milestone ID | Text29 | MHHS Programme Phase | Action | Tier |
| --- | --- | --- | --- | --- | --- | --- | --- | --- | --- | --- | --- | --- | --- | --- | --- | --- | --- | --- | --- | --- | --- | --- | --- | --- | --- | --- | --- | --- | --- | --- | --- |
| 1673 | 1.5.7.9 | **Placing Reliance - Code Body & LDSO Non Functional and Operational** |  | 49d | 2024-06-17 A | 2024-08-22 A |  | 100% |  | 2024-06-17 | 2024-08-22 | 49d |  |  |  |  |  | -0 | N/A | N/A | Non-SIT LDSO Qualification | -100.67 | 5.25 | N/A |  |  |  |  |  |  |  |
| 1674 | 1.5.7.9.1 | Placing Reliance Submitted & Reviewed |  | 32d | 2024-06-17 A | 2024-07-30 A | 1611FF-10d | 100% |  | 2024-06-17 | 2024-07-30 | 32d |  |  |  |  |  |  | LDSO, Non-SIT LDSO | LDSO, Non-SIT LDSO | Non-SIT LDSO Qualification |  | 5.27 | Ben Wickins | Complete | COMPLETE |  |  |  |  |  |
| 1675 | 1.5.7.9.2 | Review and Consultation |  | 17d | 2024-07-31 A | 2024-08-22 A | 1674 | 100% |  | 2024-07-31 | 2024-08-22 | 17d |  |  |  |  |  |  | Non-SIT LDSO | LDSO, Non-SIT LDSO | Non-SIT LDSO Qualification |  | 5.27 | Ben Wickins | Complete | COMPLETE |  |  |  |  |  |
| 1676 | 1.5.7.9.3 | PP Test Scope Presented at QAG | milestone | 0d | 2024-08-22 A | 2024-08-22 A | 1675, 1672 | 100% |  | 2024-08-22 | 2024-08-22 | 0d |  |  |  |  |  |  | Non-SIT LDSO | LDSO, Non-SIT LDSO | Non-SIT LDSO Qualification |  | 5.29 | Ben Wickins | Complete | COMPLETE | T3-QU-0077 | QAG (Non-SIT LDSO) |  |  |  |
| 1677 | 1.5.8 | **LDSO Test Readiness Reporting** |  | 71d | 2024-04-19 A | 2024-07-26 A |  | 100% |  | 2024-04-19 | 2024-07-26 | 118d |  |  |  |  |  | -0 | N/A | N/A | Non-SIT LDSO Qualification |  | 5.24 | N/A |  |  |  |  |  |  |  |
| 1678 | 1.5.8.1 | Interim Test Readiness Report & Plan Developed & Reviewed |  | 71d | 2024-04-19 A | 2024-07-26 A | 1629 | 100% |  | 2024-04-19 | 2024-07-26 | 71d |  |  |  |  |  |  | Non-SIT LDSO, LDSO | Non-SIT LDSO, LDSO | Non-SIT LDSO Qualification |  | 5.24 | Ben Wickins | Complete | COMPLETE |  |  |  |  |  |
| 1679 | 1.5.8.2 | Test Plan Submission to MHHS Programme For Review | milestone | 0d | 2024-07-26 A | 2024-07-26 A | 1678 | 100% |  | 2024-07-26 | 2024-07-26 | 0d |  |  |  |  |  |  | LDSO | Non-SIT LDSO, LDSO | Non-SIT LDSO Qualification |  | 5.30 | Ben Wickins | Complete | COMPLETE | T3-QU-0114 | QAG (Non-SIT LDSO) |  |  |  |
| 1680 | 1.5.9 | **Test Environment** |  | 163d | 2024-04-17 A | 2024-11-29 |  | 38% | 100.26d | 2024-04-17 | 2024-11-29 | 111d | 2024-01-29 | 2024-07-05 | 67d |  |  | -0 | N/A | N/A | Non-SIT LDSO Qualification |  | 5.24 | N/A |  |  |  |  | Systems Integration Testing (SIT) |  |  |
| 1681 | 1.5.9.1 | Define Test Harness Requirements and Sign-Off with SRO |  | 13d | 2024-04-17 A | 2024-05-03 A | 513 | 100% |  | 2024-04-17 | 2024-05-03 | 13d |  |  |  |  |  |  | Non-SIT LDSO | Non-SIT LDSO,SRO,Sims and Ems | Non-SIT LDSO Qualification |  | 5.24 | Ben Wickins | Complete | COMPLETE |  |  |  |  |  |
| 1682 | 1.5.9.2 | Central System (DIP Env & Helix Test Harness) Test Environment DBT |  | 163d | 2024-04-17 A | 2024-11-29 | 513 | 57% | 70d | 2024-04-17 | 2024-11-29 | 92d |  |  | 67d | 0d | finish no earlier than 2024-11-29 |  | LDSO | Non SIT-LDSO, LDSO | Non-SIT LDSO Qualification |  | 5.24 | Ben Wickins | Green | GREEN |  |  |  |  |  |
| 1683 | 1.5.9.3 | Coordinate LDSO Environment Preparation |  | 101d | 2024-07-12 | 2024-11-29 | 1682FF |  |  | 2024-07-12 | 2024-11-29 | 30d |  |  | 67d | 0d |  |  | Non-SIT LDSO | Non-SIT LDSO | Non-SIT LDSO Qualification | -110.67 | 5.24 | Ben Wickins | Overdue Start | GREEN |  |  |  |  |  |
| 1684 | 1.5.9.4 | DIP available for Onboarding |  | 1d | 2024-08-01 A | 2024-08-01 A |  | 100% |  | 2024-08-01 | 2024-08-01 | 1d |  |  |  |  | start no earlier than 2024-08-01 |  | Test Env | Test Env, Non-SIT LDSO | Non-SIT LDSO Qualification |  | 5.24 | Ben Wickins | Complete | COMPLETE |  |  |  | 11/3: Ask Simon B for the link |  |
| 1685 | 1.5.9.5 | Qualification Testing for Non-SIT LDSOs Participants' environments) Ready to start DIP onboarding (incl. certificates and security compliance) | milestone | 0d | 2024-08-05 A | 2024-08-05 A | 1684FS+2d | 100% |  | 2024-08-05 | 2024-08-05 | 0d | 2024-04-26 | 2024-04-26 |  |  |  |  | Non-SIT LDSO | Code Bodies, PP, IPA | Non-SIT LDSO Qualification |  | 5.30 | Ben Wickins | Complete | COMPLETE | T3-QU-0009 | QAG (Non-SIT LDSO) | Systems Integration Testing (SIT) |  | T3 |
| 1686 | 1.5.9.6 | LDSO Test Environments Connection Confirmed to UIT Environment | milestone | 0d | 2024-11-29 | 2024-11-29 | 1685FS+32d, 1683 |  |  | 2024-11-29 | 2024-11-29 | 0d |  |  | 67d | 25d |  |  | Non-SIT LDSO | Code Bodies, PP, IPA | Non-SIT LDSO Qualification | 29.71 | 5.24 | Ben Wickins | Green | GREEN | T3-QU-0078 | QAG (Non-SIT LDSO) |  |  |  |
| 1687 | 1.5.10 | **Test Readiness** |  | 124d | 2024-07-02 A | 2024-12-20 |  | 31% | 85.31d | 2024-07-02 | 2024-12-20 | 76d |  |  | 784d |  |  | -0 | N/A | N/A | Non-SIT LDSO Qualification |  | 5.24 | N/A |  |  |  |  |  |  |  |
| 1688 | 1.5.10.1 | Preparation for Interim Test Readiness Report |  | 19d | 2024-07-02 A | 2024-07-26 A | 1662 | 100% |  | 2024-07-02 | 2024-07-26 | 30d |  |  |  |  |  |  | LDSO | LDSO, Non-SIT LDSO | Non-SIT LDSO Qualification |  | 5.24 | Ben Wickins | Complete | COMPLETE |  |  |  |  |  |
| 1689 | 1.5.10.2 | Interim Test Readiness Report Submission to MHHS Programme for Review | milestone | 0d | 2024-07-26 A | 2024-07-26 A | 1688 | 100% |  | 2024-07-26 | 2024-07-26 | 0d |  |  |  |  |  |  | LDSO | Non-SIT LDSO, LDSO | Non-SIT LDSO Qualification |  | 5.25 | Ben Wickins | Complete | COMPLETE | T3-QU-0116 | QAG (Non-SIT LDSO) |  |  |  |
| 1690 | 1.5.10.3 | LDSO Update Readiness Report & Final Assurance by Programme |  | 99d | 2024-07-29 A | 2024-12-12 | 1689 | 20% | 79d | 2024-07-29 | 2024-12-12 | 25d |  |  | 42d | 0d |  |  | Non-SIT LDSO, LDSO | Non-SIT LDSO, LDSO | Non-SIT LDSO Qualification |  | 5.24 | Ben Wickins | Green | GREEN |  |  |  |  |  |
| 1691 | 1.5.10.4 | Final Test Readiness Report Submitted to MHHS Programme |  | 1d | 2024-12-13 | 2024-12-13 | 1690 |  |  | 2024-12-13 | 2024-12-13 | 1d |  |  | 784d | 0d |  |  | LDSO | Non-SIT LDSO, Code Bodies | Non-SIT LDSO Qualification | 43.33 | 5.24 | Ben Wickins | Green | GREEN |  |  |  |  |  |
| 1692 | 1.5.10.5 | Final Programme Assurance of LDSO Test Readiness |  | 6d | 2024-12-13 | 2024-12-20 | 1690 |  |  | 2024-12-13 | 2024-12-20 | 21d |  |  | 42d | 0d |  |  | Non-SIT LDSO | Non-SIT LDSO, LDSO | Non-SIT LDSO Qualification | 43.33 | 5.24 | Ben Wickins | Green | GREEN |  |  |  |  |  |
| 1693 | 1.5.10.6 | Qualification Testing for Non-SIT LDSOs (Functional, Migration, NFT, Operational) Programme Test Readiness confirmed | milestone | 0d | 2024-12-20 | 2024-12-20 | 1691FS+5d, 1666, 1639, 1641, 1643, 1681 |  |  | 2024-12-20 | 2024-12-20 | 0d | 2024-07-05 | 2024-07-05 | 784d |  |  |  | Non-SIT LDSO | SI Test, PP, Non-SIT LDSO | Non-SIT LDSO Qualification | 50.71 | 5.24 | Ben Wickins | Green | GREEN | T3-QU-0007 | QAG (Non-SIT LDSO) | Systems Integration Testing (SIT) |  | T3 |
| 1694 | 1.5.10.7 | Qualification Testing for Non-SIT LDSOs (Functional, Migration, NFT, Operational) Test Readiness Confirmed (Final Test Readiness Review for LDSO) | milestone | 0d | 2024-12-20 | 2024-12-20 | 1690, 1692 |  |  | 2024-12-20 | 2024-12-20 | 0d | 2024-07-05 | 2024-07-05 | 42d | 0d |  |  | LDSO | SI Test, PP, LDSO | Non-SIT LDSO Qualification | 50.71 | 5.24 | Ben Wickins | Green | GREEN | T2-QU-0550 | QAG (Non-SIT LDSO) | Systems Integration Testing (SIT) |  |  |
| 1695 | 1.5.11 | **Test Window** |  | 94d? | 2025-01-06 | 2025-05-16 |  |  |  | 2025-01-06 | 2025-05-16 | 59d |  |  | 42d |  |  | -0 | N/A | N/A | Non-SIT LDSO Qualification | -527.67 | 6.0 | N/A |  |  |  |  |  |  |  |
| 1696 | 1.5.11.1 | **All Non-SIT LDSOs Qualification Testing** |  | 94d? | 2025-01-06 | 2025-05-16 | 1694, 1686 |  |  | 2025-01-06 | 2025-05-16 | 59d |  |  | 42d | 10d |  |  | LDSO | Non-SIT LDSO,Code Bodies, LDSO | Non-SIT LDSO Qualification | 118.33 | 6.0 | Ben Wickins |  |  |  |  |  |  |  |
| 1697 | 1.5.11.1.1 | Non-SIT LDSO QT Test Execution Starts | milestone | 0d | 2025-01-06 | 2025-01-06 | 1694FS+11d |  |  | 2025-01-06 | 2025-01-06 | 0d |  |  | 42d | 0d | start no earlier than 2024-11-01 |  | Non-SIT LDSO | Non-SIT LDSO, LDSO, Code Bodies | Non-SIT LDSO Qualification | 67.71 | 6.0 | Ben Wickins | Green | GREEN | T3-QU-0115 | QAG (Non-SIT LDSO) |  |  |  |
| 1698 | 1.5.11.1.2 | Non-SIT LDSO QT - Migration Testing |  | 20d? | 2025-01-06 | 2025-01-31 | 1697FS-1d |  |  | 2025-01-06 | 2025-01-31 | 0d |  |  | 42d | 0d |  |  |  |  | Non-SIT LDSO Qualification | 67.33 | 6.0 |  | Green | GREEN | T3-QU-0125 |  |  |  |  |
| 1699 | 1.5.11.1.3 | Non-SIT LDSO QT - Functional Testing |  | 40d? | 2025-02-03 | 2025-03-28 | 1698 |  |  | 2025-02-03 | 2025-03-28 | 0d |  |  | 42d | 0d |  |  |  |  | Non-SIT LDSO Qualification | 95.33 | 6.0 |  | Green | GREEN | T3-QU-0126 |  |  |  |  |
| 1700 | 1.5.11.1.4 | Non-SIT LDSO QT - Operational Testing |  | 15d? | 2025-03-31 | 2025-04-18 | 1699 |  |  | 2025-03-31 | 2025-04-18 | 0d |  |  | 52d | 0d |  |  |  |  | Non-SIT LDSO Qualification | 151.33 | 6.0 |  | Green | GREEN | T3-QU-0127 |  |  |  |  |
| 1701 | 1.5.11.1.5 | Non-SIT LDSO QT - Non-Functional Testing |  | 15d? | 2025-04-21 | 2025-05-09 | 1700, 1667 |  |  | 2025-04-21 | 2025-05-09 | 0d |  |  | 52d |  |  |  |  |  | Non-SIT LDSO Qualification | 172.33 | 6.0 |  | Green | GREEN | T3-QU-0128 |  |  |  |  |
| 1702 | 1.5.11.1.6 | Non-SIT LDSO QT - Regression Testing |  | 30d? | 2025-03-31 | 2025-05-09 | 1699 |  |  | 2025-03-31 | 2025-05-09 | 0d |  |  | 42d | 4d |  |  |  |  | Non-SIT LDSO Qualification | 151.33 | 6.0 |  | Green | GREEN | T3-QU-0129 |  |  |  |  |
| 1703 | 1.5.11.1.7 | Qualification Testing for Non-SIT LDSOs (Functional, Migration, NFT, Operational) 1 End | milestone | 0d | 2025-05-16 | 2025-05-16 | 1702 |  |  | 2025-05-16 | 2025-05-16 | 0d |  |  | 38d | 0d | start no earlier than 2025-05-16 |  |  |  | Non-SIT LDSO Qualification | 197.33 | 6.0 |  | Green | GREEN | T3-QU-0010 |  |  |  |  |

Notes:
- 1676: Guidance: 18/7/24: Date change from 18/7/24 to 22/8/24 approved at QAG on 18/7/24
- 1682: 25/09 - End date updated to 29th November.
- 1683: 21/10/24 - MSP issue means completion % can only be 0% or 100%, have left at 0% because not complete but this is on track and RAG'd Green.
- 1690: 25/09/24 - End date amended to 20/12/24.
- 1693: Date will be missed due to deferral of QT window. Forecast date expected to be 20/12/24 and team on track to deliver against this, but can only be confirmed as baseline once CR55 is formally approved.
- 1694: 13/5: New milestone approved as part of cr47.
- 1696: 17/09/24: New milestones added and date shifted in line with programme recalibration.
- 1703: 13/5: No change as part of cr47

| ID | WBS | Task | Type | Duration | Start | Finish | Predecessors | Complete | Remaining | Baseline start | Baseline finish | Baseline duration | Baseline 1 start | Baseline 1 finish | Total slack | Free slack | Constraint | Baseline cost | Responsible | Involved | Text9 | Update Version | MHHS Resource Name | Task Status | Sched Status | RAG | Milestone ID | Text29 | MHHS Programme Phase |
| --- | --- | --- | --- | --- | --- | --- | --- | --- | --- | --- | --- | --- | --- | --- | --- | --- | --- | --- | --- | --- | --- | --- | --- | --- | --- | --- | --- | --- | --- |
| 1704 | 1.5.12 | **Test Result Assurance** |  | 29d | 2025-04-21 | 2025-05-29 |  |  |  | 2025-04-21 | 2025-05-29 | 60d |  |  | 38d |  |  | -0 | N/A | N/A | Non-SIT LDSO Qualification | 6.0 | N/A |  |  |  |  |  |  |
| 1705 | 1.5.12.1 | LDSOs Develop & Submit Test Report (QT Test Completion Report) |  | 19d | 2025-04-21 | 2025-05-16 | 1703FF |  |  | 2025-04-21 | 2025-05-16 | 19d |  |  | 38d | 0d |  |  | LDSO | Non-SIT LDSO, LDSO | Non-SIT LDSO Qualification | 6.0 | Ben Wickins | 172.33 | Green | GREEN |  |  |  |
| 1706 | 1.5.12.2 | Test Reports Reviewed By MHHS & Code Bodies & Finalised |  | 10d | 2025-05-16 | 2025-05-29 | 1705 |  |  | 2025-05-16 | 2025-05-29 | 16d |  |  | 38d | 0d |  |  | Non-SIT LDSO | Non-SIT LDSO, Code Bodies | Non-SIT LDSO Qualification | 6.0 | Ben Wickins | 197.33 | Green | GREEN |  |  |  |
| 1707 | 1.5.12.3 | Non-SIT LDSOs submission deadline for their QT Test Completion Report to MHHS Programme | milestone | 0d | 2025-05-29 | 2025-05-29 | 1706, 1696 |  |  | 2025-05-29 | 2025-05-29 | 0d |  |  | 38d | 0d |  |  | Non-SIT LDSO | Non-SIT LDSO | Non-SIT LDSO Qualification | 6.0 | Ben Wickins | 210.71 | Green | GREEN | T3-QU-0079 | QAG (Non-SIT LDSO) |  |
| 1708 | 1.5.13 | **Non-SIT LDSO Qualification Closure** |  | 61d | 2025-05-30 | 2025-08-22 |  |  |  | 2025-05-30 | 2025-08-22 | 49d |  |  | 22d |  |  | -0 | N/A | N/A | Non-SIT LDSO Qualification | 6.0 | N/A |  |  |  |  |  |  |
| 1709 | 1.5.13.1 | Non-SIT LDSO Qualification Learned Captured |  | 15d | 2025-05-30 | 2025-06-19 | 1707 |  |  | 2025-05-30 | 2025-06-19 | 15d |  |  | 38d | 0d |  |  | Non-SIT LDSO | Non-SIT LDSO | Non-SIT LDSO Qualification | 6.0 | Ben Wickins | 211.33 | Green | GREEN |  |  |  |
| 1710 | 1.5.13.2 | Non-SIT LDSO Qualification Closure Down |  | 5d | 2025-06-20 | 2025-06-26 | 1709 |  |  | 2025-06-20 | 2025-06-26 | 5d |  |  | 38d | 16d |  |  | Non-SIT LDSO | Non-SIT LDSO | Non-SIT LDSO Qualification | 6.0 | Ben Wickins | 232.33 | Green | GREEN |  |  |  |
| 1711 | 1.5.13.3 | BSC PAB & REC Manager approval of Qualification for Non-SIT LDSOs (Start of Migration for Qualification Participants) | milestone | 0d | 2025-08-22 | 2025-08-22 | 1800, 1801, 1710FS+25d |  |  | 2025-08-22 | 2025-08-22 | 0d |  |  | 22d | 0d |  |  | Non-SIT LDSO | Non-SIT LDSO | Non-SIT LDSO Qualification | 6.0 | Ben Wickins | 295.71 | Green | GREEN | T2-QU-0500 | QAG (Non-SIT LDSO) |  |
| 1712 | 1.6 | **S & A QUALIFICATION** |  | 843d | 2023-11-07 A | 2027-01-28 |  | 38% | 518.74d | 2023-11-07 | 2027-01-28 | 603d | 2024-01-29 | 2024-07-05 | 235d |  |  | -0 | N/A | N/A | S&A Qualification |  | N/A | -461.67 |  |  |  |  | Systems Integration Testing (SIT) |
| 1713 | 1.6.1 | **MHHS Qualification - Qualification Deliverables** |  | 463d | 2023-11-07 A | 2025-08-14 |  | 92% | 35.89d | 2023-11-07 | 2025-08-14 | 349d |  |  | 605d |  |  | -0 | N/A | N/A | S&A Qualification | 5.24 | N/A | -131.67 |  |  |  |  |  |
| 1714 | 1.6.1.1 | **BSC & REC Assessment Criteria** |  | 463d | 2023-11-07 A | 2025-08-14 A |  | 100% |  | 2023-11-07 | 2025-08-14 | 212d |  |  |  |  |  | -0 | N/A | N/A | S&A Qualification | 5.24 | N/A | -131.67 |  |  |  |  |  |
| 1715 | 1.6.1.1.1 | Draft BSC Assessment Criteria (Functional) |  | 21d | 2023-11-07 A | 2023-12-05 A |  | 100% |  | 2023-11-07 | 2023-12-05 | 21d |  |  |  |  | finish no earlier than 2023-12-05 |  | Code Bodies | Code Bodies | S&A Qualification | 5.24 | Laura Kennedy |  | Complete | COMPLETE |  |  |  |
| 1716 | 1.6.1.1.2 | BSC PAB Review |  | 1d | 2023-12-14 A | 2023-12-14 A |  | 100% |  | 2023-12-14 | 2023-12-14 | 1d |  |  |  |  | start no earlier than 2023-12-14 |  | Code Bodies | Code Bodies | S&A Qualification | 5.24 | Laura Kennedy |  | Complete | COMPLETE |  |  |  |
| 1717 | 1.6.1.1.3 | Update BSC Assessment Criteria (Functional, Non-Functional, Migration) |  | 30d | 2024-02-07 A | 2024-03-19 A |  | 100% |  | 2024-02-07 | 2024-03-19 | 30d |  |  |  |  | finish no earlier than 2024-03-19 |  | Code Bodies | Code Bodies | S&A Qualification | 5.24 | Laura Kennedy |  | Complete | COMPLETE |  |  |  |
| 1718 | 1.6.1.1.4 | REC & BSC PAB Approval |  | 3d | 2024-03-26 A | 2024-03-28 A |  | 100% |  | 2024-03-26 | 2024-03-28 | 3d |  |  |  |  | start no earlier than 2024-03-28 |  | Code Bodies | Code Bodies | S&A Qualification | 5.24 | Laura Kennedy |  | Complete | COMPLETE |  |  |  |
| 1719 | 1.6.1.1.5 | Update BSC Assessment Criteria (Functional, Non-Functional, Migration, Operational) |  | 20d | 2024-07-24 A | 2024-08-20 A |  | 100% |  | 2024-07-24 | 2024-08-20 | 20d |  |  |  |  |  |  | Code Bodies | Code Bodies | S&A Qualification | 5.24 | Laura Kennedy |  | Complete | COMPLETE |  |  |  |
| 1720 | 1.6.1.1.6 | Assessment Criteria (Functional, Non-Functional, Migration, Operational) Approved by REC PAB and BSC PAB |  | 250d | 2024-08-29 A | 2025-08-14 A | 1719FS+7d | 100% |  | 2024-08-29 | 2025-08-14 | 0d |  |  |  |  | start no earlier than 2023-09-15 |  | Code Bodies | Code Bodies | S&A Qualification | 5.25 | Laura Kennedy |  | Complete | COMPLETE | T3-QU-0080 | QAG |  |
| 1721 | 1.6.1.2 | **Qualification Approach and Plan** |  | 194d | 2023-12-04 A | 2024-08-29 A |  | 100% |  | 2023-12-04 | 2024-08-29 | 194d |  |  |  |  |  | -0 | N/A | N/A | S&A Qualification | 5.24 | N/A | -131.67 |  |  |  |  |  |
| 1722 | 1.6.1.2.1 | **Qualification Approach and Plan v2** |  | 84d | 2023-12-04 A | 2024-03-28 A |  | 100% |  | 2023-12-04 | 2024-03-28 | 84d |  |  |  |  |  | -0 | N/A | N/A | S&A Qualification | 5.24 | N/A | -131.67 |  |  |  |  |  |
| 1723 | 1.6.1.2.1.1 | Draft Qualification Approach and Plan v2 |  | 30d | 2023-12-04 A | 2024-01-12 A |  | 100% |  | 2023-12-04 | 2024-01-12 | 30d |  |  |  |  | finish no earlier than 2024-01-12 |  | Code Bodies | Code Bodies | S&A Qualification | 5.24 | Laura Kennedy |  | Complete | COMPLETE |  |  |  |
| 1724 | 1.6.1.2.1.2 | Internal Review (Code Bodies and MHHSP) for Qualification Approach and Plan V2 |  | 10d | 2024-01-15 A | 2024-01-26 A | 1723 | 100% |  | 2024-01-15 | 2024-01-26 | 10d |  |  |  |  | finish no earlier than 2024-01-26 |  | Code Bodies, SI Team, SRO | Code Bodies, SI Team, SRO | S&A Qualification | 5.24 | Laura Kennedy |  | Complete | COMPLETE |  |  |  |
| 1725 | 1.6.1.2.1.3 | Industry consultation for Qualification Approach and Plan v2 |  | 11d | 2024-01-31 A | 2024-02-14 A | 1724 | 100% |  | 2024-01-31 | 2024-02-14 | 11d |  |  |  |  | start no earlier than 2024-01-31 |  | Participants | Participants | S&A Qualification | 5.24 | Laura Kennedy |  | Complete | COMPLETE |  |  |  |
| 1726 | 1.6.1.2.1.4 | Update Qualification Approach and Plan v2 post industry consultation |  | 10d | 2024-02-15 A | 2024-02-28 A | 1725 | 100% |  | 2024-02-15 | 2024-02-28 | 10d |  |  |  |  |  |  | Code Bodies | Code Bodies | S&A Qualification | 5.24 | Laura Kennedy |  | Complete | COMPLETE |  |  |  |
| 1727 | 1.6.1.2.1.5 | QWG Endorsement of Qualification Approach and Plan v2 |  | 1d | 2024-03-12 A | 2024-03-12 A |  | 100% |  | 2024-03-12 | 2024-03-12 | 1d |  |  |  |  | start no earlier than 2024-03-12 |  | Code Bodies | Code Bodies | S&A Qualification | 5.24 | Laura Kennedy |  | Complete | COMPLETE |  |  |  |
| 1728 | 1.6.1.2.1.6 | QAG Approval of Qualification Approach and Plan v2 |  | 1d | 2024-03-21 A | 2024-03-21 A |  | 100% |  | 2024-03-21 | 2024-03-21 | 1d |  |  |  |  | start no earlier than 2024-03-21 |  | Code Bodies | Code Bodies | S&A Qualification | 5.24 | Laura Kennedy |  | Complete | COMPLETE |  |  |  |
| 1729 | 1.6.1.2.1.7 | BSC and REC PAB Approval of Qualification Approach and Plan v2 |  | 3d | 2024-03-26 A | 2024-03-28 A |  | 100% |  | 2024-03-26 | 2024-03-28 | 3d |  |  |  |  | finish no earlier than 2024-03-28 |  | Code Bodies | Code Bodies | S&A Qualification | 5.24 | Laura Kennedy |  | Complete | COMPLETE |  |  |  |
| 1730 | 1.6.1.2.1.8 | Functional Testing elements of Qualification Approach & Plan v2 approvement by REC PAB and BSC PAB | milestone | 0d | 2024-03-28 A | 2024-03-28 A | 1729 | 100% |  | 2024-03-28 | 2024-03-28 | 0d |  |  |  |  |  |  | Code Bodies | Code Bodies | S&A Qualification | 5.24 | Laura Kennedy |  | Complete | COMPLETE | T3-QU-0063 | QAG |  |
| 1731 | 1.6.1.2.1.9 | Migration Testing elements of Qualification Approach & Plan v2 appoved by REC PAB and BSC PAB | milestone | 0d | 2024-03-28 A | 2024-03-28 A | 1729 | 100% |  | 2024-03-28 | 2024-03-28 | 0d |  |  |  |  |  |  | Code Bodies | Code Bodies | S&A Qualification | 5.24 | Laura Kennedy |  | Complete | COMPLETE | T3-QU-0064 | QAG |  |

Notes:
- 1707: 25/09/24 - Baseline finish to be updated once CR55 formally approved, this will be 29/05/25. In the meantime, team is still assessing the impact this new forecast date will have on NF PIT timelines.
- 1711: 13/5: name changed as part of cr47.
- 1720: Assessment criteria is going to PAB for approval on 26/09/24, expecetd to be complete.

| ID | WBS | Task | Type | Duration | Start | Finish | Predecessors | Complete | Remaining | Baseline start | Baseline finish | Baseline duration | Total slack | Constraint | Baseline cost | Responsible | Involved | Text9 | Task Status | Update Version | MHHS Resource Name | Sched Status | RAG | Milestone ID | Text29 |
| --- | --- | --- | --- | --- | --- | --- | --- | --- | --- | --- | --- | --- | --- | --- | --- | --- | --- | --- | --- | --- | --- | --- | --- | --- | --- |
| 1732 | 1.6.1.2.2 | **Qualification Approach and Plan v3** |  | 84d | 2024-05-06 A | 2024-08-29 A |  | 100% |  | 2024-05-06 | 2024-08-29 | 84d |  |  | -0 | N/A | N/A | S&A Qualification | -133.67 | 5.24 | N/A |  |  |  |  |
| 1733 | 1.6.1.2.2.1 | Draft Qualification Approach and Plan v3 |  | 35d | 2024-05-06 A | 2024-06-21 A | 1076 | 100% |  | 2024-05-06 | 2024-06-21 | 35d |  | finish no earlier than 2024-05-17 |  | Code Bodies | Code Bodies | S&A Qualification |  | 5.27 | Laura Kennedy | Complete | COMPLETE |  |  |
| 1734 | 1.6.1.2.2.2 | Internal Review (Code Bodies and MHHSP) of Qualification Approach and Plan v3 |  | 10d | 2024-06-24 A | 2024-07-05 A | 1733 | 100% |  | 2024-06-24 | 2024-07-05 | 10d |  |  |  | Code Bodies, SI Team, SRO | Code Bodies, SI Team, SRO | S&A Qualification |  | 5.27 | Laura Kennedy | Complete | COMPLETE |  |  |
| 1735 | 1.6.1.2.2.3 | Industry consultation for Qualification Approach and Plan v3 |  | 10d | 2024-07-08 A | 2024-07-19 A | 1734 | 100% |  | 2024-07-08 | 2024-07-19 | 10d |  |  |  | Participants | Participants | S&A Qualification |  | 5.27 | Laura Kennedy | Complete | COMPLETE |  |  |
| 1736 | 1.6.1.2.2.4 | Update Qualification Approach and Plan v3 Post-Consultation |  | 10d | 2024-07-22 A | 2024-08-02 A | 1735 | 100% |  | 2024-07-22 | 2024-08-02 | 10d |  |  |  | Code Bodies | Code Bodies | S&A Qualification |  | 5.27 | Laura Kennedy | Complete | COMPLETE |  |  |
| 1737 | 1.6.1.2.2.5 | QWG Endorsement of Qualification Approach and Plan v3 |  | 1d | 2024-08-13 A | 2024-08-13 A | 1736FS+6d | 100% |  | 2024-08-13 | 2024-08-13 | 1d |  |  |  | Code Bodies | Code Bodies | S&A Qualification |  | 5.27 | Laura Kennedy | Complete | COMPLETE |  |  |
| 1738 | 1.6.1.2.2.6 | QAG Approval of Qualification Approach and Plan v3 | milestone | 0d | 2024-08-22 A | 2024-08-22 A | 1737FS+7d | 100% |  | 2024-08-22 | 2024-08-22 | 0d |  |  |  | Code Bodies | Code Bodies | S&A Qualification |  | 5.27 | Laura Kennedy | Complete | COMPLETE | T3-QU-0081 | QAG |
| 1739 | 1.6.1.2.2.7 | BSC and REC PAB Approval of Qualification Approach and Plan v3 |  | 3d | 2024-08-27 A | 2024-08-29 A | 1738FS+2d | 100% |  | 2024-08-27 | 2024-08-29 | 3d |  |  |  | Code Bodies | Code Bodies | S&A Qualification |  | 5.27 | Laura Kennedy | Complete | COMPLETE |  |  |
| 1740 | 1.6.1.2.2.8 | Non-Functional Testing elements of Qualification Approach and Plan v3 approved by REC PAB and BSC PAB | milestone | 0d | 2024-08-29 A | 2024-08-29 A | 1739 | 100% |  | 2024-08-29 | 2024-08-29 | 0d |  |  |  | Code Bodies | Code Bodies | S&A Qualification |  | 5.27 | Laura Kennedy | Complete | COMPLETE | T3-QU-0065 | QAG |
| 1741 | 1.6.1.3 | **Qualification Assessment Document** |  | 346d | 2023-12-22 A | 2025-04-18 |  | 81% | 66.11d | 2023-12-22 | 2025-03-07 | 316d | 689d |  | -0 | N/A | N/A | S&A Qualification | -131.67 | 5.24 | N/A |  |  |  |  |
| 1742 | 1.6.1.3.1 | **Qualification Assessment Document v1** |  | 70d | 2023-12-22 A | 2024-03-28 A |  | 100% |  | 2023-12-22 | 2024-03-28 | 70d |  |  | -0 | N/A | N/A | S&A Qualification | -131.67 | 5.24 | N/A |  |  |  |  |
| 1743 | 1.6.1.3.1.1 | Draft Qualification Assessment Document v1 |  | 30d | 2023-12-22 A | 2024-02-01 A |  | 100% |  | 2023-12-22 | 2024-02-01 | 30d |  | finish no earlier than 2024-02-01 |  | Code Bodies | Code Bodies | S&A Qualification |  | 5.24 | Laura Kennedy | Complete | COMPLETE |  |  |
| 1744 | 1.6.1.3.1.2 | Internal Review (Code Bodies and MHHSP) of Qualification Assessment Document v1 |  | 10d | 2024-02-01 A | 2024-02-14 A |  | 100% |  | 2024-02-01 | 2024-02-14 | 10d |  | finish no earlier than 2024-02-14 |  | Code Bodies, SI Team, SRO | Code Bodies, SI Team, SRO | S&A Qualification |  | 5.24 | Laura Kennedy | Complete | COMPLETE |  |  |
| 1745 | 1.6.1.3.1.3 | Industry consultation for Qualification Assessment Document v1 |  | 11d | 2024-02-16 A | 2024-03-01 A |  | 100% |  | 2024-02-16 | 2024-03-01 | 11d |  | start no earlier than 2024-02-16 |  | Participants | Participants | S&A Qualification |  | 5.24 | Laura Kennedy | Complete | COMPLETE |  |  |
| 1746 | 1.6.1.3.1.4 | Update Post-Consultation for Qualification Assessment Document v1 |  | 10d | 2024-03-04 A | 2024-03-15 A | 1745 | 100% |  | 2024-03-04 | 2024-03-15 | 10d |  |  |  | Code Bodies | Code Bodies | S&A Qualification |  | 5.24 | Laura Kennedy | Complete | COMPLETE |  |  |
| 1747 | 1.6.1.3.1.5 | BSC and REC PAB Approval of Qualification Assessment Document v1 |  | 3d | 2024-03-26 A | 2024-03-28 A |  | 100% |  | 2024-03-26 | 2024-03-28 | 3d |  | start no earlier than 2024-03-26 |  | Code Bodies | Code Bodies | S&A Qualification |  | 5.24 | Laura Kennedy | Complete | COMPLETE |  |  |
| 1748 | 1.6.1.3.1.6 | Qualification Assessment Document v1 approved by REC PAB and BSC PAB | milestone | 0d | 2024-03-28 A | 2024-03-28 A | 1747 | 100% |  | 2024-03-28 | 2024-03-28 | 0d |  |  |  | Code Bodies | Code Bodies | S&A Qualification |  | 5.24 | Laura Kennedy | Complete | COMPLETE | T3-QU-0066 | QAG |
| 1749 | 1.6.1.3.2 | **Qualification Assessment Document v3** |  | 110d | 2024-03-29 A | 2024-08-29 A |  | 100% |  | 2024-03-29 | 2024-08-29 | 110d |  |  | -0 | N/A | N/A | S&A Qualification | -131.67 | 5.24 | N/A |  |  |  |  |
| 1750 | 1.6.1.3.2.1 | Draft Qualification Assessment Document V1.1 |  | 26d | 2024-03-29 A | 2024-05-03 A | 1748 | 100% |  | 2024-03-29 | 2024-05-03 | 26d |  |  |  |  |  | S&A Qualification |  | 5.24 | Laura Kennedy | Complete | COMPLETE |  |  |
| 1751 | 1.6.1.3.2.2 | Industry Consultation for Qualification Assessment Document V1.1 |  | 12d | 2024-05-06 A | 2024-05-21 A | 1750 | 100% |  | 2024-05-06 | 2024-05-21 | 12d |  |  |  |  |  | S&A Qualification |  | 5.24 | Laura Kennedy | Complete | COMPLETE |  |  |
| 1752 | 1.6.1.3.2.3 | Draft Qualification Assessment Document v3 |  | 6d | 2024-06-14 A | 2024-06-21 A | 1160, 1751 | 100% |  | 2024-06-14 | 2024-06-21 | 6d |  |  |  | Code Bodies | Code Bodies | S&A Qualification |  | 5.24 | Laura Kennedy | Complete | COMPLETE |  |  |
| 1753 | 1.6.1.3.2.4 | Internal Review (Code Bodies and MHHSP) of Qualification Assessment Document v3 |  | 10d | 2024-06-24 A | 2024-07-05 A | 1752 | 100% |  | 2024-06-24 | 2024-07-05 | 10d |  |  |  | Code Bodies, SI Team, SRO | Code Bodies, SI Team, SRO | S&A Qualification |  | 5.24 | Laura Kennedy | Complete | COMPLETE |  |  |
| 1754 | 1.6.1.3.2.5 | Industry consultation for Qualification Assessment Document v3 |  | 10d | 2024-07-08 A | 2024-07-19 A | 1753 | 100% |  | 2024-07-08 | 2024-07-19 | 10d |  |  |  | Participants | Participants | S&A Qualification |  | 5.24 | Laura Kennedy | Complete | COMPLETE |  |  |
| 1755 | 1.6.1.3.2.6 | Update Post-Consultation for Qualification Assessment Document v3 |  | 10d | 2024-07-22 A | 2024-08-02 A | 1754 | 100% |  | 2024-07-22 | 2024-08-02 | 10d |  |  |  | Code Bodies | Code Bodies | S&A Qualification |  | 5.24 | Laura Kennedy | Complete | COMPLETE |  |  |
| 1756 | 1.6.1.3.2.7 | QWG Endorsement of Qualification Assessment Document v3 |  | 1d | 2024-08-13 A | 2024-08-13 A | 1755FS+6d | 100% |  | 2024-08-13 | 2024-08-13 | 1d |  |  |  | Code Bodies | Code Bodies | S&A Qualification |  | 5.24 | Laura Kennedy | Complete | COMPLETE |  |  |
| 1757 | 1.6.1.3.2.8 | QAG Endorsement of Qualification Assessment Document v3 |  | 1d | 2024-08-22 A | 2024-08-22 A | 1756FS+6d | 100% |  | 2024-08-22 | 2024-08-22 | 1d |  |  |  | Code Bodies | Code Bodies | S&A Qualification |  | 5.25 | Laura Kennedy | Complete | COMPLETE | T3-QU-0083 | QAG |
| 1758 | 1.6.1.3.2.9 | BSC and REC PAB Approval of Qualification Assessment Document v3 |  | 3d | 2024-08-27 A | 2024-08-29 A | 1757FS+2d | 100% |  | 2024-08-27 | 2024-08-29 | 3d |  |  |  | Code Bodies | Code Bodies | S&A Qualification |  | 5.24 | Laura Kennedy | Complete | COMPLETE |  |  |
| 1759 | 1.6.1.3.2.10 | Qualification Assessment Document v3 approved by REC PAB and BSC PAB | milestone | 0d | 2024-08-29 A | 2024-08-29 A | 1758 | 100% |  | 2024-08-29 | 2024-08-29 | 0d |  |  |  | Code Bodies | Code Bodies | S&A Qualification |  | 5.24 | Laura Kennedy | Complete | COMPLETE | T3-QU-0067 | QAG |

Notes:
- 1738: Approved at QAG on 22/08/24.
- 1757: Approved at QAG on 22/08/24.

| ID | WBS | Task | Type | Duration | Start | Finish | Predecessors | Complete | Remaining | Baseline start | Baseline finish | Baseline duration | Baseline 1 start | Baseline 1 finish | Total slack | Free slack | Constraint | Baseline cost | Responsible | Involved | Text9 | Task Status | Update Version | MHHS Resource Name | Sched Status | RAG | Milestone ID | Text29 | MHHS Programme Phase |
| --- | --- | --- | --- | --- | --- | --- | --- | --- | --- | --- | --- | --- | --- | --- | --- | --- | --- | --- | --- | --- | --- | --- | --- | --- | --- | --- | --- | --- | --- |
| 1760 | 1.6.1.3.3 | **Qualification Assessment Document Portal** |  | 315d | 2024-02-05 A | 2025-04-18 |  | 65% | 110.53d | 2024-02-05 | 2025-03-07 | 285d |  |  | 689d |  |  | -0 | N/A | N/A | S&A Qualification | -131.67 | 5.24 | N/A |  |  |  |  |  |
| 1761 | 1.6.1.3.3.1 | Design Completion |  | 30d | 2024-02-05 A | 2024-03-15 A |  | 100% |  | 2024-02-05 | 2024-03-15 | 30d |  |  |  |  | finish no earlier than 2024-03-15 |  | QAD Portal Dev Team | QAD Portal Dev Team | S&A Qualification |  | 5.24 | Laura Kennedy | Complete | COMPLETE |  |  |  |
| 1762 | 1.6.1.3.3.2 | Qualification Assessment Document Portal Build |  | 30d | 2024-03-18 A | 2024-04-26 A | 1761 | 100% |  | 2024-03-18 | 2024-04-26 | 30d |  |  |  |  |  |  | QAD Portal Dev Team | QAD Portal Dev Team | S&A Qualification |  | 5.24 | Laura Kennedy | Complete | COMPLETE |  |  |  |
| 1763 | 1.6.1.3.3.3 | Qualification Assessment Document Internal Testing |  | 20d | 2024-04-29 A | 2024-05-24 A | 1762 | 100% |  | 2024-04-29 | 2024-05-24 | 20d |  |  |  |  |  |  | QAD Portal Dev Team. Code Bodies | QAD Portal Dev Team. Code Bodies | S&A Qualification |  | 5.24 | Laura Kennedy | Complete | COMPLETE |  |  |  |
| 1764 | 1.6.1.3.3.4 | Qualification Assessment Document Portal Training and Onboarding Material Creation |  | 20d | 2024-05-27 A | 2024-06-21 A | 1763 | 100% |  | 2024-05-27 | 2024-06-21 | 20d |  |  |  |  |  |  | QAD Portal Dev Team | QAD Portal Dev Team | S&A Qualification |  | 5.24 | Laura Kennedy | Complete | COMPLETE |  |  |  |
| 1765 | 1.6.1.3.3.5 | Qualification Assessment Document Portal Webinar (Date TBC) |  | 1d | 2024-06-18 A | 2024-06-18 A |  | 100% |  | 2024-06-18 | 2024-06-18 | 1d |  |  |  |  | start no earlier than 2024-06-18 |  | QAD Portal Dev Team | QAD Portal Dev Team | S&A Qualification |  | 5.24 | Laura Kennedy | Complete | COMPLETE |  |  |  |
| 1766 | 1.6.1.3.3.6 | SIT Participant QAD Application Creation in Portal |  | 10d | 2024-12-09 | 2024-12-20 | 1764FS+120d |  |  | 2024-12-09 | 2024-12-20 | 10d |  |  | 774d | 0d |  |  | Code Bodies | Code Bodies | S&A Qualification | 39.33 | 5.24 | Laura Kennedy | Green | GREEN |  |  |  |
| 1767 | 1.6.1.3.3.7 | Non-SIT LDSO Participant QAD Application Creation in Portal |  | 10d | 2024-12-09 | 2024-12-20 | 1764FS+120d |  |  | 2024-12-09 | 2024-12-20 | 10d |  |  | 773d | 0d |  |  | Code Bodies | Code Bodies | S&A Qualification | 39.33 | 5.24 | Laura Kennedy | Green | GREEN |  |  |  |
| 1768 | 1.6.1.3.3.8 | QT Wave 1 Participant QAD Application Creation in Portal |  | 10d | 2025-04-07 | 2025-04-18 | 1764FS+205d |  |  | 2025-04-07 | 2025-04-18 | 10d |  |  | 6d | 0d |  |  | Code Bodies | Code Bodies | S&A Qualification | 158.33 | 6.1 | Laura Kennedy | Green | GREEN |  |  |  |
| 1769 | 1.6.1.3.3.9 | QT Wave 2 Participant QAD Application Creation in Portal |  | 10d | 2024-10-28 | 2024-11-08 | 1764FS+90d |  |  | 2024-10-28 | 2024-11-08 | 10d |  |  | 6d | 0d |  |  | Code Bodies | Code Bodies | S&A Qualification | -2.67 | 6.1 | Laura Kennedy | Green | GREEN |  |  |  |
| 1770 | 1.6.1.3.3.10 | QT Wave 3 Participant QAD Application Creation in Portal |  | 10d | 2024-12-30 | 2025-01-10 | 1764FS+135d |  |  | 2024-12-30 | 2025-01-10 | 10d |  |  | 0d |  |  |  | Code Bodies | Code Bodies | S&A Qualification | 60.33 | 6.1 | Laura Kennedy | Green | GREEN |  |  |  |
| 1771 | 1.6.1.3.3.11 | QT Wave 4 Participant QAD Application Creation in Portal |  | 10d | 2025-02-24 | 2025-03-07 | 1764FS+175d |  |  | 2025-02-24 | 2025-03-07 | 10d |  |  | 4d | 0d |  |  | Code Bodies | Code Bodies | S&A Qualification | 116.33 | 6.1 | Laura Kennedy | Green | GREEN |  |  |  |
| 1772 | 1.6.1.3.3.12 | Update to Qualification Assessment Document Portal post QAD V3 |  | 10d | 2024-08-30 A | 2024-09-12 A | 1759 | 100% |  | 2024-08-30 | 2024-09-12 | 10d |  |  |  |  |  |  | QAD Portal Dev Team | QAD Portal Dev Team | S&A Qualification |  | 6.1 | Laura Kennedy | Complete | COMPLETE |  |  |  |
| 1773 | 1.6.1.3.3.13 | Update to Qualification Assessment Document Portal post QAD V3 Complete | milestone | 0d | 2024-09-12 A | 2024-09-12 A | 1772 | 100% |  | 2024-09-12 | 2024-09-12 | 0d |  |  |  |  |  |  | QAD Portal Dev Team | QAD Portal Dev Team | S&A Qualification |  | 6.1 | Laura Kennedy | Complete | COMPLETE | T3-QU-0084 | QAG |  |
| 1774 | 1.6.2 | **MHHS Qualification - SIT Participants** |  | 251d | 2025-01-06 | 2025-12-22 |  |  |  | 2025-01-06 | 2025-12-22 | 194d | 2024-01-29 | 2024-07-05 | 60d |  |  | -0 | N/A | N/A | S&A Qualification | -133.67 | 6.11 | N/A |  |  |  |  | Systems Integration Testing (SIT) |
| 1775 | 1.6.2.1 | Initial QAD Submission Window opens | milestone | 0d | 2025-01-06 | 2025-01-06 | 1766FS+10d |  |  | 2025-01-06 | 2025-01-06 | 0d |  |  | 774d |  | start no earlier than 2025-01-06 |  | Participants | Participants | S&A Qualification | 67.33 | 6.11 | Laura Kennedy | Green | GREEN |  |  |  |
| 1776 | 1.6.2.2 | SIT Participants submit Initial QAD |  | 30d | 2025-01-06 | 2025-02-14 |  |  |  | 2025-01-06 | 2025-02-14 | 29d |  |  | 60d | 0d | start no earlier than 2025-01-06 |  | Participants | Participants | S&A Qualification | 67.33 | 6.11 | Laura Kennedy | Green | GREEN |  |  |  |
| 1777 | 1.6.2.3 | Code Bodies review Initial QAD |  | 36d | 2025-02-14 | 2025-04-04 | 1776FS-1d |  |  | 2025-02-14 | 2025-04-04 | 36d |  |  | 60d | 0d |  |  | Code Bodies | Code Bodies | S&A Qualification | 106.33 | 6.11 | Laura Kennedy | Green | GREEN |  |  |  |
| 1778 | 1.6.2.4 | Completion of Code Bodies review of Initial QAD | milestone | 0d | 2025-04-04 | 2025-04-04 | 1777 |  |  | 2025-04-04 | 2025-04-04 | 0d |  |  | 60d | 0d |  |  | Code Bodies | Code Bodies | S&A Qualification | 155.71 | 6.11 | Laura Kennedy | Green | GREEN |  |  |  |
| 1779 | 1.6.2.5 | **MHHS Qualification - SIT MVC Participants** |  | 114d | 2025-04-07 | 2025-09-11 |  |  |  | 2025-04-07 | 2025-09-11 | 64d |  |  | 5d |  |  |  | N/A | N/A | S&A Qualification | -154.67 | 6.11 | N/A |  |  |  |  |  |
| 1780 | 1.6.2.5.1 | Final QAD Submission Window (MVC) opens | milestone | 0d | 2025-04-07 | 2025-04-07 | 1777, 1773, 1778FS+1d |  |  | 2025-04-07 | 2025-04-07 | 0d |  |  | 60d | 0d |  |  | Participants | Participants | S&A Qualification | 158.71 | 6.11 | Laura Kennedy | Green | GREEN |  |  |  |
| 1781 | 1.6.2.5.2 | SIT MVC Participants submit Final QAD |  | 25d | 2025-04-07 | 2025-05-09 | 1780FS-1d |  |  | 2025-04-07 | 2025-05-09 | 26d |  |  | 60d | 0d |  |  | Participants | Participants | S&A Qualification | 158.33 | 6.11 | Laura Kennedy | Green | GREEN |  |  |  |
| 1782 | 1.6.2.5.3 | Completion of Code Bodies review of Final QAD (MVC) |  | 20d | 2025-05-12 | 2025-06-06 | 1781, 1442FF |  |  | 2025-05-12 | 2025-06-06 | 19d |  |  | 60d | 55d |  |  | Code Bodies | Code Bodies | S&A Qualification | 193.33 | 6.11 | Laura Kennedy | Green | GREEN |  |  |  |
| 1783 | 1.6.2.5.4 | QAD Sign Off Deadline (MVC) | milestone | 0d | 2025-08-22 | 2025-08-22 | 1451, 1782 |  |  | 2025-08-22 | 2025-08-22 | 1d |  |  | 5d | 0d | start no earlier than 2025-07-11 |  | Participants | Participants | S&A Qualification | 295.71 | 6.11 | Laura Kennedy | Green | GREEN |  |  |  |
| 1784 | 1.6.2.5.5 | REC Code Manager / BSC PAB Approval of Qualification (MVC) | milestone | 0d | 2025-09-11 | 2025-09-11 | 1783FS+14d |  |  | 2025-09-11 | 2025-09-11 | 0d |  |  | 5d | 0d |  |  | Code Bodies | Code Bodies | S&A Qualification | 315.71 | 6.11 | Laura Kennedy | Green | GREEN | T3-QU-0085 | QAG |  |

Notes:
- 1766: 25/09/24 - These should move to start a week before the QAD window.
- 1767: 25/09/24 - These should move to start a week before the QAD window.
- 1768: 25/09/24 - These should move to start a week before the QAD window.
- 1769: 25/09/24 - Proposed that this is removed and replaced with a milestone for Batch 3 of Functional Tests, but this has not yet been confirmed.
- 1775: 25/09/24 - Forecast has moved to 06/01/25, this will be baseliend once CR55 is approved.
- 1776: 25/09/24 - Forecast has moved to 13/02/25, this will be baseliend once CR55 is approved.
- 1777: 25/09/24 - Forecast has moved to 04/04/25, this will be baseliend once CR55 is approved.
- 1778: 25/09/24 - Forecast has moved to 04/04/25, this will be baseliend once CR55 is approved.
- 1780: 25/09/24 - Forecast has moved to 04/04/25, this will be baseliend once CR55 is approved.
- 1784: 6/8/24: Date at risk from scenario planning activity

| ID | WBS | Task | Type | Duration | Start | Finish | Predecessors | Complete | Remaining | Baseline start | Baseline finish | Baseline duration | Total slack | Free slack | Constraint | Baseline cost | Responsible | Involved | Text9 | Task Status | Update Version | MHHS Resource Name | Sched Status | RAG | Milestone ID | Text29 |
| --- | --- | --- | --- | --- | --- | --- | --- | --- | --- | --- | --- | --- | --- | --- | --- | --- | --- | --- | --- | --- | --- | --- | --- | --- | --- | --- |
| 1785 | 1.6.2.6 | **MHHS Qualification - SIT Non-MVC Participants** |  | 156d | 2025-05-19 | 2025-12-22 |  |  |  | 2025-05-19 | 2025-12-22 | 129d | 25d |  |  |  | N/A | N/A | S&A Qualification | -154.67 | 6.11 | N/A |  |  |  |  |
| 1786 | 1.6.2.6.1 | Final QAD Submission Window (Non-MVC) opens | milestone | 0d | 2025-05-19 | 2025-05-19 | 1778FS+31d |  |  | 2025-05-19 | 2025-05-19 | 0d | 134d | 0d |  |  | Participants | Participants | S&A Qualification | 200.71 | 6.11 | Laura Kennedy | Green | GREEN |  |  |
| 1787 | 1.6.2.6.2 | SIT Non-MVC Participants submit Final QAD |  | 90d | 2025-05-19 | 2025-09-19 | 1786SS-1d |  |  | 2025-05-19 | 2025-09-19 | 86d | 45d | 0d |  |  | Participants | Participants | S&A Qualification | 200.33 | 6.11 | Laura Kennedy | Green | GREEN |  |  |
| 1788 | 1.6.2.6.3 | Completion of Code Bodies review of Final QAD (Non-MVC) |  | 25d | 2025-09-22 | 2025-10-24 | 1787 |  |  | 2025-09-22 | 2025-10-24 | 19d | 45d | 20d |  |  | Code Bodies | Code Bodies | S&A Qualification | 326.33 | 6.11 | Laura Kennedy | Green | GREEN |  |  |
| 1789 | 1.6.2.6.4 | QAD Sign Off Deadline (Non-MVC) |  | 1d | 2025-11-28 | 2025-11-28 | 1788FS+4d, 1473 |  |  | 2025-11-28 | 2025-11-28 | 1d | 25d | 0d |  |  | Participants | Participants | S&A Qualification | 393.33 | 6.11 | Laura Kennedy | Green | GREEN |  |  |
| 1790 | 1.6.2.6.5 | REC Code Manager / BSC PAB Approval of Qualification (Non-MVC) | milestone | 0d | 2025-12-22 | 2025-12-22 | 1789FS+16d |  |  | 2025-12-22 | 2025-12-22 | 0d | 25d | 0d |  |  | Code Bodies | Code Bodies | S&A Qualification | 417.71 | 6.11 | Laura Kennedy | Green | GREEN | T3-QU-0086 | QAG |
| 1791 | 1.6.3 | **MHHS Qualification - Non-SIT LDSO** |  | 179d | 2025-01-06 | 2025-09-11 |  |  |  | 2025-01-06 | 2025-09-11 | 115d | 71d |  |  | -0 | N/A | N/A | S&A Qualification | -133.67 | 6.11 | N/A |  |  |  |  |
| 1792 | 1.6.3.1 | Initial QAD Submission window opens | milestone | 0d | 2025-01-06 | 2025-01-06 | 1767FS+11d |  |  | 2025-01-06 | 2025-01-06 | 0d | 773d |  |  |  | Participants | Participants | S&A Qualification | 67.71 | 6.11 | Laura Kennedy | Green | GREEN |  |  |
| 1793 | 1.6.3.2 | Non-SIT LDSO Participants submit initial QAD |  | 30d | 2025-01-06 | 2025-02-14 |  |  |  | 2025-01-06 | 2025-02-14 | 29d | 71d | 0d | start no earlier than 2025-01-06 |  | Participants | Participants | S&A Qualification | 67.33 | 6.11 | Laura Kennedy | Green | GREEN |  |  |
| 1794 | 1.6.3.3 | Non-SIT LDSO QT Participants have submitted their initial QAD | milestone | 0d | 2025-02-14 | 2025-02-14 | 1793 |  |  | 2025-02-14 | 2025-02-14 | 0d | 71d | 0d |  |  | Participants | Participants | S&A Qualification | 106.71 | 6.11 | Laura Kennedy | Green | GREEN | T3-QU-0087 | QAG |
| 1795 | 1.6.3.4 | Code Bodies review of Non-SIT LDSO participants Initial QAD |  | 35d | 2025-02-17 | 2025-04-04 | 1794 |  |  | 2025-02-17 | 2025-04-04 | 36d | 71d | 0d |  |  | Code Bodies | Code Bodies | S&A Qualification | 109.33 | 6.11 | Laura Kennedy | Green | GREEN |  |  |
| 1796 | 1.6.3.5 | Completion of Code Bodies review of Initial QAD | milestone | 0d | 2025-04-04 | 2025-04-04 | 1795 |  |  | 2025-04-04 | 2025-04-04 | 0d | 71d | 0d |  |  | Code Bodies | Code Bodies | S&A Qualification | 155.71 | 6.11 | Laura Kennedy | Green | GREEN |  |  |
| 1797 | 1.6.3.6 | Final QAD Submission window opens | milestone | 0d | 2025-04-07 | 2025-04-07 | 1796FS+1d |  |  | 2025-04-07 | 2025-04-07 | 0d | 71d | 9d |  |  | Participants | Participants | S&A Qualification | 158.71 | 6.11 | Laura Kennedy | Green | GREEN |  |  |
| 1798 | 1.6.3.7 | Non-SIT LDSO Participants submit Final QAD |  | 25d | 2025-04-21 | 2025-05-23 | 1705SS, 1797SS |  |  | 2025-04-21 | 2025-05-23 | 26d | 62d | 0d |  |  | Participants | Participants | S&A Qualification | 172.33 | 6.11 | Laura Kennedy | Green | GREEN |  |  |
| 1799 | 1.6.3.8 | Non-SIT LDSO QT Participants have submitted their final QAD | milestone | 0d | 2025-05-23 | 2025-05-23 | 1798 |  |  | 2025-05-23 | 2025-05-23 | 0d | 62d | 0d |  |  | Participants | Participants | S&A Qualification | 204.71 | 6.11 | Laura Kennedy | Green | GREEN | T3-QU-0088 | QAG |
| 1800 | 1.6.3.9 | Completion of Code Bodies review of the Final QAD |  | 20d | 2025-05-26 | 2025-06-20 | 1799 |  |  | 2025-05-26 | 2025-06-20 | 19d | 62d | 40d |  |  | Code Bodies | Code Bodies | S&A Qualification | 207.33 | 6.11 | Laura Kennedy | Green | GREEN |  |  |
| 1801 | 1.6.3.10 | QAD Sign Off Deadline (Non-SIT LDSOs) | milestone | 0d | 2025-08-22 | 2025-08-22 | 1800FS+5d, 1451 |  |  | 2025-08-22 | 2025-08-22 | 1d | 22d | 0d |  |  | Participants | Participants | S&A Qualification | 295.71 | 6.11 | Laura Kennedy | Green | GREEN |  |  |
| 1802 | 1.6.3.11 | BSC PAB & REC Manager approval of Qualification for Non-SIT LDSOs (Start of Migration for Qualification Participants) | milestone | 0d | 2025-09-11 | 2025-09-11 | 1703, 1801FS+14d |  |  | 2025-09-11 | 2025-09-11 | 0d | 595d |  |  |  | Non-SIT LDSO | Non-SIT LDSO | S&A Qualification | 315.71 | 6.11 | Ben Wickins | Green | GREEN | T2-QU-0500 | QAG (Non-SIT LDSO) |
| 1803 | 1.6.4 | **MHHS Qualification - Qualification Waves** |  | 814d | 2023-12-18 A | 2027-01-28 |  | 30% | 567.79d | 2023-12-18 | 2027-01-28 | 574d | 235d |  |  | -0 | N/A | N/A | S&A Qualification | -131.67 | 5.24 | N/A |  |  |  |  |
| 1804 | 1.6.4.1 | **Qualification Wave Prep** |  | 560d | 2023-12-18 A | 2026-02-06 |  | 58% | 235.92d | 2023-12-18 | 2025-12-26 | 424d | 489d |  |  | -0 | N/A | N/A | S&A Qualification | -131.67 | 5.24 | N/A |  |  |  |  |
| 1805 | 1.6.4.1.1 | **Non-SIT Supplier and Agent Test Approach and Plan** |  | 119d | 2023-12-18 A | 2024-05-30 A |  | 100% |  | 2023-12-18 | 2024-05-30 | 118d |  |  |  | -0 | N/A | N/A | S&A Qualification | -133.67 | 5.24 | N/A |  |  |  |  |
| 1806 | 1.6.4.1.1.1 | Draft Non-SIT S&A Test Approach and Plan |  | 50d | 2023-12-18 A | 2024-02-23 A |  | 100% |  | 2023-12-18 | 2024-02-23 | 50d |  |  | finish no earlier than 2024-02-23 |  | Non-SIT S&A QT Test Team | Non-SIT S&A QT Test Team | S&A Qualification |  | 5.24 | Laura Kennedy | Complete | COMPLETE |  |  |
| 1807 | 1.6.4.1.1.2 | Internal Review of Non-SIT S&A Test Approach and Plan (Code Bodies and MHHSP) |  | 10d | 2024-02-26 A | 2024-03-08 A | 1806 | 100% |  | 2024-02-26 | 2024-03-08 | 10d |  |  |  |  | Code Bodies, SI Team, SRO | Code Bodies, SI Team, SRO | S&A Qualification |  | 5.24 | Laura Kennedy | Complete | COMPLETE |  |  |
| 1808 | 1.6.4.1.1.3 | Issue Non-SIT S&A Test Approach and Plan for Consultation |  | 15d | 2024-03-18 A | 2024-04-05 A | 1807 | 100% |  | 2024-03-18 | 2024-04-05 | 15d |  |  | start no earlier than 2024-03-18 |  | Participants | Participants | S&A Qualification |  | 5.24 | Laura Kennedy | Complete | COMPLETE |  |  |
| 1809 | 1.6.4.1.1.4 | Update Non-SIT S&A Test Approach and Plan Post-Consultation |  | 10d | 2024-04-08 A | 2024-04-19 A | 1808 | 100% |  | 2024-04-08 | 2024-04-19 | 10d |  |  |  |  | Non-SIT S&A QT Test Team | Non-SIT S&A QT Test Team | S&A Qualification |  | 5.24 | Laura Kennedy | Complete | COMPLETE |  |  |
| 1810 | 1.6.4.1.1.5 | QWG Endorsement of Non-SIT S&A Test Approach and Plan |  | 1d | 2024-05-14 A | 2024-05-14 A |  | 100% |  | 2024-05-14 | 2024-05-14 | 1d |  |  | finish no earlier than 2024-05-14 |  | Non-SIT S&A QT Test Team | Non-SIT S&A QT Test Team | S&A Qualification |  | 5.24 | Laura Kennedy | Complete | COMPLETE |  |  |
| 1811 | 1.6.4.1.1.6 | QAG Approval of Non-SIT S&A Test Approach and Plan | milestone | 0d | 2024-05-23 A | 2024-05-23 A | 1810FS+7d | 100% |  | 2024-05-23 | 2024-05-23 | 0d |  |  |  |  | Non-SIT S&A QT Test Team | Non-SIT S&A QT Test Team | S&A Qualification |  | 5.25 | Laura Kennedy | Complete | COMPLETE | T3-QU-0089 | QAG |
| 1812 | 1.6.4.1.1.7 | BSC & REC PAB Approval of Non-SIT S&A Test Approach and Plan | milestone | 0d | 2024-05-30 A | 2024-05-30 A | 1811FS+5d | 100% |  | 2024-05-30 | 2024-05-30 | 0d |  |  |  |  | Code Bodies | Code Bodies | S&A Qualification |  | 5.25 | Laura Kennedy | Complete | COMPLETE | T3-QU-0090 | QAG |

Notes:
- 1786: 25/09/24 - Forecast has moved to 07/04/25, this will be baseliend once CR55 is approved.
- 1790: 6/8/24: Date at risk from scenario planning activity
- 1792: 25/09/24 - Forecast has moved to 06/01/25, this will be baseliend once CR55 is approved.
- 1793: 25/09/24 - Forecast has moved to 13/02/25, this will be baseliend once CR55 is approved.
- 1794: 28/08/24 - Date will be missed because the date for the initial QAD submission window has been moved back to reflect the delay to SIT activities and to provide Programme PPs with more time to prepare. Milestone date change was approved at QAG on 22/08/24, from 10/10/24 to 10/11/24. To go to 19/09/24 QAG for noting.
- 1795: 25/09/24 - Forecast has moved to 04/04/25, this will be baseliend once CR55 is approved.
- 1796: 25/09/24 - Forecast has moved to 04/04/25, this will be baseliend once CR55 is approved.
- 1797: 25/09/24 - Forecast has moved to 07/04/25, this will be baseliend once CR55 is approved.
- 1799: 6/8/24: Date at risk from scenario planning activity
- 1801: 18/09/24 - Adding dependency so the milestone is dependent on SIT LDSO MVC.
- 1802: 13/5: name changed as part of cr47.

| ID | WBS | Task | Type | Duration | Start | Finish | Predecessors | Complete | Baseline start | Baseline finish | Baseline duration | Total slack | Free slack | Constraint | Baseline cost | Responsible | Involved | Text9 | Task Status | Update Version | MHHS Resource Name | Sched Status | RAG | Milestone ID | Text29 |
| --- | --- | --- | --- | --- | --- | --- | --- | --- | --- | --- | --- | --- | --- | --- | --- | --- | --- | --- | --- | --- | --- | --- | --- | --- | --- |
| 1813 | 1.6.4.1.2 | **QT Test Data Approach and Plan** |  | 64d | 2024-04-19 A | 2024-07-18 A |  | 100% | 2024-04-19 | 2024-07-18 | 64d |  |  |  | -0 | N/A | N/A | S&A Qualification | -133.67 | 5.24 | N/A |  |  |  |  |
| 1814 | 1.6.4.1.2.1 | QT Test Data Approach agreed as part of the Non-SIT Supplier and Agent Test Approach and Plan | milestone | 0d | 2024-04-19 A | 2024-04-19 A | 1809 | 100% | 2024-04-19 | 2024-04-19 | 0d |  |  |  |  | Non-SIT S&A QT Test Team, Participants | Non-SIT S&A QT Test Team, Participants | S&A Qualification |  | 5.24 | Laura Kennedy | Complete | COMPLETE |  |  |
| 1815 | 1.6.4.1.2.2 | Draft Test Data Approach and Plan for QT |  | 10d | 2024-05-06 A | 2024-05-17 A | 1814 | 100% | 2024-05-06 | 2024-05-17 | 10d |  |  |  |  | Non-SIT S&A QT Test Team | Non-SIT S&A QT Test Team | S&A Qualification |  | 5.24 | Laura Kennedy | Complete | COMPLETE |  |  |
| 1816 | 1.6.4.1.2.3 | Internal Review (Code Bodies and MHHSP) of QT Test Data Approach and Plan |  | 15d | 2024-05-20 A | 2024-06-07 A | 1815 | 100% | 2024-05-20 | 2024-06-07 | 10d |  |  |  |  | Code Bodies, SI Team, SRO | Code Bodies, SI Team, SRO | S&A Qualification |  | 5.24 | Laura Kennedy | Complete | COMPLETE |  |  |
| 1817 | 1.6.4.1.2.4 | Issue QT Test Data Approach and Plan for Industry Consultation |  | 10d | 2024-06-10 A | 2024-06-21 A | 1816 | 100% | 2024-06-10 | 2024-06-21 | 10d |  |  |  |  | Participants | Participants | S&A Qualification |  | 5.24 | Laura Kennedy | Complete | COMPLETE |  |  |
| 1818 | 1.6.4.1.2.5 | Update QT Test Approach and Plan Post Industry Consultation |  | 5d | 2024-06-24 A | 2024-06-28 A | 1817 | 100% | 2024-06-24 | 2024-06-28 | 10d |  |  |  |  | Non-SIT S&A QT Team | Non-SIT S&A QT Team | S&A Qualification |  | 5.24 | Laura Kennedy | Complete | COMPLETE |  |  |
| 1819 | 1.6.4.1.2.6 | QWG Endorsement of Test Data Approach and Plan |  | 1d | 2024-07-09 A | 2024-07-09 A | 1818FS+6d | 100% | 2024-07-09 | 2024-07-09 | 1d |  |  |  |  | Non-SIT S&A QT Test Team | Non-SIT S&A QT Test Team | S&A Qualification |  | 5.24 | Laura Kennedy | Complete | COMPLETE |  |  |
| 1820 | 1.6.4.1.2.7 | QAG Approval of QT Test Data Approach and Plan | milestone | 0d | 2024-07-18 A | 2024-07-18 A | 1819FS+7d | 100% | 2024-07-18 | 2024-07-18 | 0d |  |  |  |  | Non-SIT S&A QT Test Team | Non-SIT S&A QT Test Team | S&A Qualification |  | 5.29 | Laura Kennedy | Complete | COMPLETE | T3-QU-0091 | QAG |
| 1821 | 1.6.4.1.3 | **QT Functional Test Scenarios and Test Cases** |  | 59d | 2024-03-04 A | 2024-05-23 A |  | 100% | 2024-03-04 | 2024-05-23 | 59d |  |  |  | -0 | N/A | N/A | S&A Qualification | -133.67 | 5.24 | N/A |  |  |  |  |
| 1822 | 1.6.4.1.3.1 | Draft Test Scenarios and Test Case list - Batch 1 |  | 10d | 2024-03-04 A | 2024-03-15 A |  | 100% | 2024-03-04 | 2024-03-15 | 10d |  |  | finish no earlier than 2024-03-15 |  | Non-SIT S&A QT Test Team, Code Bodies | Non-SIT S&A QT Test Team, Code Bodies | S&A Qualification |  | 5.24 | Laura Kennedy | Complete | COMPLETE |  |  |
| 1823 | 1.6.4.1.3.2 | Issue Batch 1 for Consultation |  | 15d | 2024-03-18 A | 2024-04-05 A | 1822 | 100% | 2024-03-18 | 2024-04-05 | 15d |  |  | start no earlier than 2024-03-18 |  | Participants | Participants | S&A Qualification |  | 5.24 | Laura Kennedy | Complete | COMPLETE |  |  |
| 1824 | 1.6.4.1.3.3 | Gap analysis against QT Requirements |  | 8d | 2024-03-18 A | 2024-03-27 A | 1822 | 100% | 2024-03-18 | 2024-03-27 | 8d |  |  |  |  | Non-SIT S&A QT Test Team | Non-SIT S&A QT Test Team | S&A Qualification |  | 5.24 | Laura Kennedy | Complete | COMPLETE |  |  |
| 1825 | 1.6.4.1.3.4 | Update Test Scenarios and Test Case list - Batch 2 |  | 6d | 2024-03-28 A | 2024-04-04 A | 1824 | 100% | 2024-03-28 | 2024-04-04 | 6d |  |  |  |  | Non-SIT S&A QT Test Team, Code Bodies | Non-SIT S&A QT Test Team, Code Bodies | S&A Qualification |  | 5.24 | Laura Kennedy | Complete | COMPLETE |  |  |
| 1826 | 1.6.4.1.3.5 | Issue Batch 2 for consultation |  | 10d | 2024-04-05 A | 2024-04-18 A | 1825 | 100% | 2024-04-05 | 2024-04-18 | 10d |  |  |  |  | Participants | Participants | S&A Qualification |  | 5.24 | Laura Kennedy | Complete | COMPLETE |  |  |
| 1827 | 1.6.4.1.3.6 | Update Batch 2 post consultation |  | 10d | 2024-04-19 A | 2024-05-02 A | 1826 | 100% | 2024-04-19 | 2024-05-02 | 10d |  |  |  |  | Non-SIT S&A QT Test Team, Code Bodies | Non-SIT S&A QT Test Team, Code Bodies | S&A Qualification |  | 5.24 | Laura Kennedy | Complete | COMPLETE |  |  |
| 1828 | 1.6.4.1.3.7 | QWG Endorsement of Batch 1 and 2 |  | 1d | 2024-05-14 A | 2024-05-14 A |  | 100% | 2024-05-14 | 2024-05-14 | 1d |  |  | finish no earlier than 2024-05-14 |  | Non-SIT S&A QT Test Team | Non-SIT S&A QT Test Team, Code Bodies, Participants | S&A Qualification |  | 5.24 | Laura Kennedy | Complete | COMPLETE |  |  |
| 1829 | 1.6.4.1.3.8 | QAG Approval of QT Functional Test Scenarios and Test Cases Batches 1 and 2 | milestone | 0d | 2024-05-23 A | 2024-05-23 A | 1828FS+7d | 100% | 2024-05-23 | 2024-05-23 | 0d |  |  |  |  | Non-SIT S&A QT Test Team | Non-SIT S&A QT Test Team, Code Bodies, Participants | S&A Qualification |  | 5.25 | Laura Kennedy | Complete | COMPLETE | T3-QU-0092 | QAG |
| 1830 | 1.6.4.1.4 | **QT Migration Test Scenarios and Test Cases** |  | 54d | 2024-05-06 A | 2024-07-18 A |  | 100% | 2024-05-06 | 2024-07-18 | 54d |  |  |  |  | N/A | N/A | S&A Qualification |  | 5.25 | N/A |  |  |  |  |
| 1831 | 1.6.4.1.4.1 | Draft Test Scenarios and Test Case list - Batch 1 |  | 20d | 2024-05-06 A | 2024-05-31 A | 997FS+12d | 100% | 2024-05-06 | 2024-05-31 | 20d |  |  |  |  | Non-SIT S&A QT Test Team, Code Bodies | Non-SIT S&A QT Test Team, Code Bodies | S&A Qualification |  | 5.25 | Laura Kennedy | Complete | COMPLETE |  |  |
| 1832 | 1.6.4.1.4.2 | Issue Batch 1 for Consultation |  | 10d | 2024-06-03 A | 2024-06-14 A | 1831 | 100% | 2024-06-03 | 2024-06-14 | 10d |  |  |  |  | Participants | Participants | S&A Qualification |  | 5.25 | Laura Kennedy | Complete | COMPLETE |  |  |
| 1833 | 1.6.4.1.4.3 | Update Batch 1 Post Consultation |  | 10d | 2024-06-17 A | 2024-06-28 A | 1832 | 100% | 2024-06-17 | 2024-06-28 | 10d |  |  |  |  | Non-SIT S&A QT Test Team | Non-SIT S&A QT Test Team | S&A Qualification |  | 5.25 | Laura Kennedy | Complete | COMPLETE |  |  |
| 1834 | 1.6.4.1.4.4 | QWG Endorsement of Batch 1 | milestone | 0d | 2024-07-09 A | 2024-07-09 A | 1833FS+7d | 100% | 2024-07-09 | 2024-07-09 | 0d |  |  |  |  | Non-SIT S&A QT Test Team | Non-SIT S&A QT Test Team, Code Bodies, Participants | S&A Qualification |  | 5.25 | Laura Kennedy | Complete | COMPLETE |  |  |
| 1835 | 1.6.4.1.4.5 | QAG Approval of QT Migration Test Scenarios and Test Cases Batches 1 | milestone | 0d | 2024-07-18 A | 2024-07-18 A | 1834FS+7d | 100% | 2024-07-18 | 2024-07-18 | 0d |  |  |  |  | Non-SIT S&A QT Test Team | Non-SIT S&A QT Test Team, Code Bodies, Participants | S&A Qualification |  | 5.29 | Laura Kennedy | Complete | COMPLETE | T3-QU-0119 | QAG |
| 1836 | 1.6.4.1.5 | **QT Functional (inc NF and Operational) Test Scenarios and Test Cases** |  | 64d | 2024-11-05 | 2025-01-31 |  |  | 2024-11-04 | 2024-12-27 | 0d | 740d |  |  |  |  |  | S&A Qualification | -721.67 |  |  |  |  |  |  |
| 1837 | 1.6.4.1.5.1 | Draft Test Scenarios and Test Case list - Batch 3 |  | 20d | 2024-11-05 | 2024-12-02 | 873FS-1d |  | 2024-11-05 | 2024-12-02 | 0d | 740d | 0d |  |  |  |  | S&A Qualification | 5.33 | 6.11 |  | Green | GREEN |  |  |
| 1838 | 1.6.4.1.5.2 | Issue Batch 3 for Consultation |  | 10d | 2024-12-03 | 2024-12-16 | 1837 |  | 2024-12-03 | 2024-12-16 | 0d | 740d | 0d |  |  |  |  | S&A Qualification | 33.33 | 6.11 |  | Green | GREEN |  |  |
| 1839 | 1.6.4.1.5.3 | Update Batch 3 Post Consultation |  | 20d | 2024-12-17 | 2025-01-13 | 1838 |  | 2024-12-17 | 2025-01-13 | 0d | 740d | 0d |  |  |  |  | S&A Qualification | 47.33 | 6.11 |  | Green | GREEN |  |  |
| 1840 | 1.6.4.1.5.4 | QWG Endorsement of Batch 3 | milestone | 0d | 2025-01-22 | 2025-01-22 | 1839FS+7d |  | 2025-01-22 | 2025-01-22 | 0d | 740d | 0d |  |  |  |  | S&A Qualification | 83.71 | 6.11 |  | Green | GREEN |  |  |
| 1841 | 1.6.4.1.5.5 | QAG Approval of QT Functional Test Scenarios and Test Cases Batches 3 | milestone | 0d | 2025-01-31 | 2025-01-31 | 1840FS+7d |  | 2025-01-31 | 2025-01-31 | 0d | 740d | 0d |  |  |  |  | S&A Qualification | 92.71 | 6.11 |  | Green | GREEN |  |  |

Notes:
- 1836: 22/10/24 - Pending QAG approval. New activity added. Need agreement at November QAG to remove Batches 1 and 2 for Migration and Operational and merge with Functional Batch 3.
- 1837: 22/10/24 - Pending QAG approval. New activity added. Need agreement at November QAG to remove Batches 1 and 2 for Migration and Operational and merge with Functional Batch 3.
- 1838: 22/10/24 - Pending QAG approval. New activity added. Need agreement at November QAG to remove Batches 1 and 2 for Migration and Operational and merge with Functional Batch 3.
- 1839: 22/10/24 - Pending QAG approval. New activity added. Need agreement at November QAG to remove Batches 1 and 2 for Migration and Operational and merge with Functional Batch 3.
- 1840: 22/10/24 - Pending QAG approval. New activity added. Need agreement at November QAG to remove Batches 1 and 2 for Migration and Operational and merge with Functional Batch 3.
- 1841: 22/10/24 - Pending QAG approval. New activity added. Need agreement at November QAG to remove Batches 1 and 2 for Migration and Operational and merge with Functional Batch 3.

| ID | WBS | Task | Type | Duration | Start | Finish | Predecessors | Complete | Remaining | Baseline start | Baseline finish | Baseline duration | Total slack | Free slack | Constraint | Baseline cost | Responsible | Involved | Text9 | Update Version | MHHS Resource Name | Task Status | RAG | Milestone ID | Text29 | Sched Status |
| --- | --- | --- | --- | --- | --- | --- | --- | --- | --- | --- | --- | --- | --- | --- | --- | --- | --- | --- | --- | --- | --- | --- | --- | --- | --- | --- |
| 1842 | 1.6.4.1.6 | **QT Non-Functional Test Scenarios and Test Cases** | inactive | 61d | 2024-09-20 | 2024-12-13 |  |  |  | 2024-09-20 | 2024-12-13 | 43d | 789d |  |  |  | N/A | N/A | S&A Qualification | 5.25 | N/A |  |  |  |  |  |
| 1843 | 1.6.4.1.6.1 | Draft Test Scenarios and Test Case list - Batch 2 | inactive | 27d | 2024-09-20 | 2024-10-28 | 1099FS+2d, 1093FS+2d |  |  | 2024-09-20 | 2024-10-28 | 10d | 789d | 0d |  |  | Non-SIT S&A QT Test Team, Code Bodies | Non-SIT S&A QT Test Team, Code Bodies | S&A Qualification | 5.25 | Laura Kennedy | -40.67 | GREEN |  |  |  |
| 1844 | 1.6.4.1.6.2 | Issue Batch 2 for Consultation | inactive | 10d | 2024-10-29 | 2024-11-11 | 1843 |  |  | 2024-10-29 | 2024-11-11 | 10d | 789d | 0d |  |  | Participants | Participants | S&A Qualification | 5.25 | Laura Kennedy | -1.67 | GREEN |  |  |  |
| 1845 | 1.6.4.1.6.3 | Update Batch 2 Post Consultation | inactive | 10d | 2024-11-12 | 2024-11-25 | 1844 |  |  | 2024-11-12 | 2024-11-25 | 10d | 789d | 0d |  |  | Non-SIT S&A QT Test Team | Non-SIT S&A QT Test Team | S&A Qualification | 5.25 | Laura Kennedy | 12.33 | GREEN |  |  |  |
| 1846 | 1.6.4.1.6.4 | QWG Endorsement of Batch 2 | milestone, inactive | 0d | 2024-12-04 | 2024-12-04 | 1845FS+7d, 1740 |  |  | 2024-12-04 | 2024-12-04 | 0d | 789d | 0d |  |  | Non-SIT S&A QT Test Team | Non-SIT S&A QT Test Team, Code Bodies, Participants | S&A Qualification | 5.25 | Laura Kennedy | 34.71 | GREEN |  |  |  |
| 1847 | 1.6.4.1.6.5 | QAG Approval of QT Non-Functional Test Scenarios and Test Cases Batch 2 | milestone, inactive | 0d | 2024-12-13 | 2024-12-13 | 1846FS+7d |  |  | 2024-12-13 | 2024-12-13 | 0d | 789d |  |  |  | Non-SIT S&A QT Test Team | Non-SIT S&A QT Test Team, Code Bodies, Participants | S&A Qualification | 5.27 | Laura Kennedy | 43.71 | AMBER | T3-QU-0120 | QAG |  |
| 1848 | 1.6.4.1.7 | **QT Operational Test Scenarios and Test Cases** | inactive | 82d | 2024-09-10 | 2025-01-01 |  |  |  | 2024-09-10 | 2025-01-01 | 63d | 776d |  |  |  | N/A | N/A | S&A Qualification | 5.25 | N/A |  |  |  |  |  |
| 1849 | 1.6.4.1.7.1 | Draft QT Operational Test Cases - Batch 1 | inactive | 47d | 2024-09-11 | 2024-11-14 | 1157FS+2d, 1820 |  |  | 2024-09-11 | 2024-11-14 | 10d | 776d | 0d |  |  | Non-SIT S&A QT Test Team, Code Bodies | Non-SIT S&A QT Test Team, Code Bodies | S&A Qualification | 5.25 | Laura Kennedy | -49.67 | GREEN |  |  |  |
| 1850 | 1.6.4.1.7.2 | Issue Batch 1 for Consultation | inactive | 10d | 2024-11-15 | 2024-11-28 | 1849 |  |  | 2024-11-15 | 2024-11-28 | 10d | 776d | 0d |  |  | Participants | Participants | S&A Qualification | 5.25 | Laura Kennedy | 15.33 | GREEN |  |  |  |
| 1851 | 1.6.4.1.7.3 | Update Batch 1 Post Consultation | inactive | 10d | 2024-11-29 | 2024-12-12 | 1850 |  |  | 2024-11-29 | 2024-12-12 | 10d | 776d | 0d |  |  | Non-SIT S&A QT Test Team | Non-SIT S&A QT Test Team | S&A Qualification | 5.25 | Laura Kennedy | 29.33 | GREEN |  |  |  |
| 1852 | 1.6.4.1.7.4 | QWG Endorsement of Batch 1 | milestone, inactive | 0d | 2024-12-23 | 2024-12-23 | 1851FS+7d |  |  | 2024-12-23 | 2024-12-23 | 0d | 776d | 0d |  |  | Non-SIT S&A QT Test Team | Non-SIT S&A QT Test Team, Code Bodies, Participants | S&A Qualification | 5.25 | Laura Kennedy | 53.71 | GREEN |  |  |  |
| 1853 | 1.6.4.1.7.5 | QAG Approval of QT Operational Test Scenarios and Test Cases Batch 1 | milestone, inactive | 0d | 2025-01-01 | 2025-01-01 | 1852FS+7d |  |  | 2025-01-01 | 2025-01-01 | 0d | 776d |  |  |  | Non-SIT S&A QT Test Team | Non-SIT S&A QT Test Team, Code Bodies, Participants | S&A Qualification | 5.27 | Laura Kennedy | 62.71 | AMBER | T3-QU-0121 | QAG |  |
| 1854 | 1.6.4.1.7.6 | Draft QT Operational Test Cases - Batch 2 | inactive | 10d | 2024-09-10 | 2024-09-23 | 1163FS+2d |  |  | 2024-09-10 | 2024-09-23 | 10d | 814d | 0d |  |  | Non-SIT S&A QT Test Team, Code Bodies | Non-SIT S&A QT Test Team, Code Bodies | S&A Qualification | 5.25 | Laura Kennedy | -50.67 | RED |  |  |  |
| 1855 | 1.6.4.1.7.7 | Issue Batch 2 for Consultation | inactive | 10d | 2024-09-24 | 2024-10-07 | 1854 |  |  | 2024-09-24 | 2024-10-07 | 10d | 814d | 0d |  |  | Participants | Participants | S&A Qualification | 5.25 | Laura Kennedy | -36.67 | RED |  |  |  |
| 1856 | 1.6.4.1.7.8 | Update Batch 2 Post Consultation | inactive | 10d | 2024-10-08 | 2024-10-21 | 1855 |  |  | 2024-10-08 | 2024-10-21 | 10d | 814d | 0d |  |  | Non-SIT S&A QT Test Team | Non-SIT S&A QT Test Team | S&A Qualification | 5.25 | Laura Kennedy | -22.67 | RED |  |  |  |
| 1857 | 1.6.4.1.7.9 | QWG Endorsement of Batch 2 | milestone, inactive | 0d | 2024-10-30 | 2024-10-30 | 1856FS+7d |  |  | 2024-10-30 | 2024-10-30 | 0d | 814d | 0d |  |  | Non-SIT S&A QT Test Team | Non-SIT S&A QT Test Team, Code Bodies, Participants | S&A Qualification | 5.25 | Laura Kennedy | -0.29 | GREEN |  |  |  |
| 1858 | 1.6.4.1.7.10 | QAG Approval of QT Operational Test Scenarios and Test Cases Batch 2 | milestone, inactive | 0d | 2024-11-08 | 2024-11-08 | 1857FS+7d |  |  | 2024-11-08 | 2024-11-08 | 0d | 814d |  |  |  | Non-SIT S&A QT Test Team | Non-SIT S&A QT Test Team, Code Bodies, Participants | S&A Qualification | 5.27 | Laura Kennedy | 8.71 | GREEN | T3-QU-0122 | QAG |  |
| 1859 | 1.6.4.1.8 | **Qualification Testing Framework (Test Stubs and Supporting UI)** |  | 530d | 2024-01-29 A | 2026-02-06 |  | 50% | 267.05d | 2024-01-29 | 2025-12-26 | 394d | 489d |  |  | -0 | N/A | N/A | S&A Qualification | 5.27 | N/A | -594.67 |  |  |  |  |
| 1860 | 1.6.4.1.8.1 | Proof of Concept for QTF Completion |  | 45d | 2024-01-29 A | 2024-03-29 A |  | 100% |  | 2024-01-29 | 2024-03-29 | 45d |  |  | start no earlier than 2024-01-22 |  | Non-SIT S&A QT Test Team | Non-SIT S&A QT Test Team | S&A Qualification | 5.27 | Laura Kennedy |  | COMPLETE |  |  | Complete |
| 1861 | 1.6.4.1.8.2 | Discovery and Mobilisation |  | 25d | 2024-04-01 A | 2024-05-03 A | 1860 | 100% |  | 2024-04-01 | 2024-05-03 | 25d |  |  |  |  | Non-SIT S&A QT Test Team | Non-SIT S&A QT Test Team | S&A Qualification | 5.27 | Laura Kennedy |  | COMPLETE |  |  | Complete |
| 1862 | 1.6.4.1.8.3 | **Agile DBT of Qualification Testing Framework** |  | 83d | 2024-04-24 A | 2024-08-16 A |  | 100% |  | 2024-04-24 | 2024-08-16 | 83d |  |  |  | -0 | N/A | N/A | S&A Qualification | 5.27 | N/A |  |  |  |  |  |
| 1863 | 1.6.4.1.8.3.1 | **User Interface (UI)** |  | 48d | 2024-04-24 A | 2024-06-28 A |  | 100% |  | 2024-04-24 | 2024-06-28 | 48d |  |  |  |  | N/A | N/A | S&A Qualification | 5.27 | N/A | -594.67 |  |  |  |  |
| 1864 | 1.6.4.1.8.3.1.1 | UI Wireframe |  | 48d | 2024-04-24 A | 2024-06-28 A | 1809FS+2d | 100% |  | 2024-04-24 | 2024-06-28 | 48d |  |  |  |  | Non-SIT S&A QT Test Team | Non-SIT S&A QT Test Team | S&A Qualification | 5.27 | Laura Kennedy |  | COMPLETE |  |  | Complete |
| 1865 | 1.6.4.1.8.3.1.2 | UI Standards |  | 35d | 2024-05-13 A | 2024-06-28 A | 1864SS+13d | 100% |  | 2024-05-13 | 2024-06-28 | 35d |  |  |  |  | Non-SIT S&A QT Test Team | Non-SIT S&A QT Test Team | S&A Qualification | 5.27 | Laura Kennedy |  | COMPLETE |  |  | Complete |
| 1866 | 1.6.4.1.8.3.1.3 | Elexon Branding Sylesheet |  | 1d | 2024-05-17 A | 2024-05-20 A | 1861FS+10d | 100% |  | 2024-05-17 | 2024-05-20 | 1d |  |  |  |  | Non-SIT S&A QT Test Team | Non-SIT S&A QT Test Team | S&A Qualification | 5.27 | Laura Kennedy |  | COMPLETE |  |  | Complete |
| 1867 | 1.6.4.1.8.3.1.4 | Elexon Branding QTF Logo |  | 1d | 2024-05-31 A | 2024-06-03 A | 1861FS+20d | 100% |  | 2024-05-31 | 2024-06-03 | 1d |  |  |  |  | Non-SIT S&A QT Test Team | Non-SIT S&A QT Test Team | S&A Qualification | 5.27 | Laura Kennedy |  | COMPLETE |  |  | Complete |

Notes:
- 1843: 25/09/24 - Pending QAG approval. Proposed that this is removed and replaced with a milestone for Batch 3 of Functional Tests.
- 1844: 25/09/24 - Pending QAG approval. Proposed that this is removed and replaced with a milestone for Batch 3 of Functional Tests.
- 1845: 25/09/24 - Pending QAG approval. Proposed that this is removed and replaced with a milestone for Batch 3 of Functional Tests.
- 1846: 25/09/24 - Pending QAG approval. Proposed that this is removed and replaced with a milestone for Batch 3 of Functional Tests.
- 1847: 25/09/24 - Pending QAG approval. Proposed that this is removed and replaced with a milestone for Batch 3 of Functional Tests.
- 1848: 25/09/24 - Pending QAG approval. Proposed that this is removed and replaced with a milestone for Batch 3 of Functional Tests.
- 1849: 25/09/24 - Pending QAG approval. Proposed that this is removed and replaced with a milestone for Batch 3 of Functional Tests. / Action: 9/7/24: Potential delay as delay from the test side. Does it need to be linked to all 3 or just 1?
- 1850: 25/09/24 - Pending QAG approval. Proposed that this is removed and replaced with a milestone for Batch 3 of Functional Tests.
- 1851: 25/09/24 - Pending QAG approval. Proposed that this is removed and replaced with a milestone for Batch 3 of Functional Tests.
- 1852: 25/09/24 - Pending QAG approval. Proposed that this is removed and replaced with a milestone for Batch 3 of Functional Tests.
- 1853: 25/09/24 - Pending QAG approval. Proposed that this is removed and replaced with a milestone for Batch 3 of Functional Tests.
- 1854: 25/09/24 - Pending QAG approval. Proposed that this is removed and replaced with a milestone for Batch 3 of Functional Tests.
- 1855: 25/09/24 - Pending QAG approval. Proposed that this is removed and replaced with a milestone for Batch 3 of Functional Tests.
- 1856: 25/09/24 - Pending QAG approval. Proposed that this is removed and replaced with a milestone for Batch 3 of Functional Tests.
- 1857: 25/09/24 - Pending QAG approval. Proposed that this is removed and replaced with a milestone for Batch 3 of Functional Tests.
- 1858: 25/09/24 - Pending QAG approval. Proposed that this is removed and replaced with a milestone for Batch 3 of Functional Tests.

| ID | WBS | Task | Duration | Start | Finish | Predecessors | Complete | Remaining | Baseline start | Baseline finish | Baseline duration | Total slack | Free slack | Baseline cost | Responsible | Involved | Text9 | Task Status | Update Version | MHHS Resource Name | Sched Status | RAG |
| --- | --- | --- | --- | --- | --- | --- | --- | --- | --- | --- | --- | --- | --- | --- | --- | --- | --- | --- | --- | --- | --- | --- |
| 1868 | 1.6.4.1.8.3.2 | **Design, Build, Test** | 70d | 2024-05-13 A | 2024-08-16 A |  | 100% |  | 2024-05-13 | 2024-08-16 | 70d |  |  |  | N/A | N/A | S&A Qualification | -594.67 | 5.27 | N/A |  |  |
| 1869 | 1.6.4.1.8.3.2.1 | Core UI Screens | 60d | 2024-05-13 A | 2024-08-02 A | 1865SS | 100% |  | 2024-05-13 | 2024-08-02 | 60d |  |  |  | Non-SIT S&A QT Test Team | Non-SIT S&A QT Test Team | S&A Qualification |  | 5.27 | Laura Kennedy | Complete | COMPLETE |
| 1870 | 1.6.4.1.8.3.2.2 | Tooling (Trigger Files / Template Generators) | 70d | 2024-05-13 A | 2024-08-16 A | 1864SS+13d | 100% |  | 2024-05-13 | 2024-08-16 | 70d |  |  |  | Non-SIT S&A QT Test Team | Non-SIT S&A QT Test Team | S&A Qualification |  | 5.27 | Laura Kennedy | Complete | COMPLETE |
| 1871 | 1.6.4.1.8.3.2.3 | Database Schema | 50d | 2024-05-13 A | 2024-07-19 A | 1864SS+13d | 100% |  | 2024-05-13 | 2024-07-19 | 50d |  |  |  | Non-SIT S&A QT Test Team | Non-SIT S&A QT Test Team | S&A Qualification |  | 5.27 | Laura Kennedy | Complete | COMPLETE |
| 1872 | 1.6.4.1.8.3.2.4 | Core API's | 60d | 2024-05-13 A | 2024-08-02 A | 1864SS+13d | 100% |  | 2024-05-13 | 2024-08-02 | 60d |  |  |  | Non-SIT S&A QT Test Team | Non-SIT S&A QT Test Team | S&A Qualification |  | 5.27 | Laura Kennedy | Complete | COMPLETE |
| 1873 | 1.6.4.1.8.3.2.5 | DIP (SIT-A) Onboarding for Development inc. Test Stubs | 1d | 2024-07-12 A | 2024-07-12 A | 1861FS+49d | 100% |  | 2024-07-12 | 2024-07-12 | 1d |  |  |  | Non-SIT S&A QT Test Team, Electralink | Non-SIT S&A QT Test Team, Electralink | S&A Qualification |  | 5.27 | Laura Kennedy | Complete | COMPLETE |
| 1874 | 1.6.4.1.8.3.2.6 | DTN Onboarding for Development inc. Test Stubs | 1d | 2024-07-15 A | 2024-07-15 A | 1873 | 100% |  | 2024-07-15 | 2024-07-15 | 1d |  |  |  | Non-SIT S&A QT Test Team, MHHSP, Avanade | Non-SIT S&A QT Test Team, MHHSP, Avanade | S&A Qualification |  | 5.27 | Laura Kennedy | Complete | COMPLETE |
| 1875 | 1.6.4.1.8.4 | QTF Test Cases DBT Refinement, Execution and Results Validation, Defect Management, Error Handling | 131d | 2024-08-02 | 2025-01-31 | 1841FF |  |  | 2024-08-02 | 2025-01-31 | 79d | 740d | 0d |  | Non-SIT S&A QT Test Team | Non-SIT S&A QT Test Team | S&A Qualification | -89.67 | 6.11 | Laura Kennedy | Overdue Start | GREEN |
| 1876 | 1.6.4.1.8.5 | **Environments** | 224d | 2024-04-15 A | 2025-02-20 |  | 54% | 103.3d | 2024-04-15 | 2025-01-21 | 158d | 740d |  | -0 | N/A | N/A | S&A Qualification | -594.67 | 5.27 | N/A |  |  |
| 1877 | 1.6.4.1.8.5.1 | **Azure Devops** | 120d | 2024-04-15 A | 2024-09-27 |  | 42% | 69.38d | 2024-04-15 | 2024-09-27 | 120d | 216d |  | -0 | N/A | N/A | S&A Qualification | -594.67 | 5.27 | N/A |  |  |
| 1878 | 1.6.4.1.8.5.1.1 | **QFT ADO Development Instance** | 15d | 2024-04-15 A | 2024-05-03 A |  | 100% |  | 2024-04-15 | 2024-05-03 | 15d |  |  |  | N/A | N/A | S&A Qualification | -594.67 | 5.27 | N/A |  |  |
| 1879 | 1.6.4.1.8.5.1.1.1 | Elexon Instance Setup for QTF Build | 5d | 2024-04-15 A | 2024-04-19 A | 1861SS+10d | 100% |  | 2024-04-15 | 2024-04-19 | 5d |  |  |  | Non-SIT S&A QT Test Team | Non-SIT S&A QT Test Team | S&A Qualification |  | 5.27 | Laura Kennedy | Complete | COMPLETE |
| 1880 | 1.6.4.1.8.5.1.1.2 | Configuration and User Access | 10d | 2024-04-22 A | 2024-05-03 A | 1879 | 100% |  | 2024-04-22 | 2024-05-03 | 10d |  |  |  | Non-SIT S&A QT Test Team | Non-SIT S&A QT Test Team | S&A Qualification |  | 5.27 | Laura Kennedy | Complete | COMPLETE |
| 1881 | 1.6.4.1.8.5.1.2 | **MHHSP ADO Instance** | 49d | 2024-07-23 A | 2024-09-27 |  | 24% | 37d | 2024-07-23 | 2024-09-27 | 50d | 216d |  |  | N/A | N/A | S&A Qualification | -594.67 | 5.27 | N/A | Complete |  |
| 1882 | 1.6.4.1.8.5.1.2.1 | MHHSP Instance Setup for QTF Production | 29d | 2024-07-23 A | 2024-08-30 | 1888SS+41d | 41% | 17d | 2024-07-23 | 2024-08-30 | 30d | 216d | 0d |  | MHHSP | MHHSP | S&A Qualification |  | 5.27 | Laura Kennedy | Overdue | RED |
| 1883 | 1.6.4.1.8.5.1.2.2 | Configuration and User Access | 20d | 2024-09-02 | 2024-09-27 | 1882, 1939 |  |  | 2024-09-02 | 2024-09-27 | 20d | 216d | 205d |  | Non-SIT S&A QT Test Team | Non-SIT S&A QT Test Team | S&A Qualification | -58.67 | 5.27 | Laura Kennedy | Overdue Start | RED |
| 1884 | 1.6.4.1.8.5.2 | **Temporary Development Environment** | 35d | 2024-04-15 A | 2024-05-31 A |  | 100% |  | 2024-04-15 | 2024-05-31 | 35d |  |  |  | N/A | N/A | S&A Qualification | -594.67 | 5.27 | N/A |  |  |
| 1885 | 1.6.4.1.8.5.2.1 | Design | 15d | 2024-04-15 A | 2024-05-03 A | 1861SS+10d | 100% |  | 2024-04-15 | 2024-05-03 | 15d |  |  |  | Non-SIT S&A QT Test Team | Non-SIT S&A QT Test Team | S&A Qualification |  | 5.27 | Laura Kennedy | Complete | COMPLETE |
| 1886 | 1.6.4.1.8.5.2.2 | Build and Deployment | 20d | 2024-05-06 A | 2024-05-31 A | 1880, 1885 | 100% |  | 2024-05-06 | 2024-05-31 | 20d |  |  |  | Non-SIT S&A QT Test Team | Non-SIT S&A QT Test Team | S&A Qualification |  | 5.27 | Laura Kennedy | Complete | COMPLETE |
| 1887 | 1.6.4.1.8.5.3 | **Dev, Test & Prod Environment Requirements + Design** | 105d | 2024-05-27 A | 2024-10-18 |  | 58% | 43.91d | 2024-05-27 | 2024-10-18 | 105d | 829d |  | -0 | N/A | N/A | S&A Qualification | -594.67 | 5.27 | N/A |  |  |
| 1888 | 1.6.4.1.8.5.3.1 | Design (including Security Review) | 70d | 2024-05-27 A | 2024-08-30 | 1861FS+15d | 76% | 17d | 2024-05-27 | 2024-08-30 | 70d | 864d | 0d |  | Non-SIT S&A QT Test Team | Non-SIT S&A QT Test Team | S&A Qualification |  | 5.27 | Laura Kennedy | Overdue | RED |
| 1889 | 1.6.4.1.8.5.3.2 | Hub Deployment | 20d | 2024-06-10 A | 2024-07-05 A | 1888SS+10d | 100% |  | 2024-06-10 | 2024-07-05 | 20d |  |  |  | Non-SIT S&A QT Test Team | Non-SIT S&A QT Test Team | S&A Qualification |  | 5.27 | Laura Kennedy | Complete | COMPLETE |
| 1890 | 1.6.4.1.8.5.3.3 | Development Envn. Deployment | 40d | 2024-07-08 A | 2024-08-30 | 1889 | 58% | 17d | 2024-07-08 | 2024-08-30 | 40d | 815d | 0d |  | Non-SIT S&A QT Test Team | Non-SIT S&A QT Test Team | S&A Qualification |  | 5.27 | Laura Kennedy | Overdue | RED |
| 1891 | 1.6.4.1.8.5.3.4 | Test Envn. Deployment | 10d | 2024-09-02 | 2024-09-13 | 1890 |  |  | 2024-09-02 | 2024-09-13 | 10d | 815d | 0d |  | Non-SIT S&A QT Test Team | Non-SIT S&A QT Test Team | S&A Qualification | -58.67 | 5.27 | Laura Kennedy | Overdue Start | RED |
| 1892 | 1.6.4.1.8.5.3.5 | Production Envn. Deployment | 25d | 2024-09-16 | 2024-10-18 | 1891 |  |  | 2024-09-16 | 2024-10-18 | 25d | 815d | 75d |  | Non-SIT S&A QT Test Team | Non-SIT S&A QT Test Team | S&A Qualification | -44.67 | 5.27 | Laura Kennedy | Overdue Start | RED |

| ID | WBS | Task | Duration | Start | Finish | Predecessors | Complete | Remaining | Baseline start | Baseline finish | Baseline duration | Total slack | Free slack | Constraint | Baseline cost | Responsible | Involved | Text9 | Task Status | Update Version | Sched Status | MHHS Resource Name | RAG |
| --- | --- | --- | --- | --- | --- | --- | --- | --- | --- | --- | --- | --- | --- | --- | --- | --- | --- | --- | --- | --- | --- | --- | --- |
| 1893 | 1.6.4.1.8.5.4 | **QTF Deployment into Production** | 14d | 2025-02-03 | 2025-02-20 |  |  |  | 2025-01-02 | 2025-01-21 | 14d | 740d |  |  |  | N/A | N/A | S&A Qualification | -594.67 | 6.11 | No BL | N/A |  |
| 1894 | 1.6.4.1.8.5.4.1 | App Deployment | 1d | 2025-02-03 | 2025-02-03 | 1875, 1892 |  |  | 2025-01-02 | 2025-01-02 | 1d | 740d | 0d |  |  | Non-SIT S&A QT Test Team | Non-SIT S&A QT Test Team | S&A Qualification | 95.33 | 6.11 | Red | Laura Kennedy | RED |
| 1895 | 1.6.4.1.8.5.4.2 | Smoke Test | 2d | 2025-02-03 | 2025-02-04 | 1894SS |  |  | 2025-01-02 | 2025-01-03 | 2d | 740d | 0d |  |  | Non-SIT S&A QT Test Team | Non-SIT S&A QT Test Team | S&A Qualification | 95.33 | 6.11 | Red | Laura Kennedy | RED |
| 1896 | 1.6.4.1.8.5.4.3 | PEN Test | 2d | 2025-02-05 | 2025-02-06 | 1895 |  |  | 2025-01-06 | 2025-01-07 | 2d | 740d | 0d |  |  | Non-SIT S&A QT Test Team | Non-SIT S&A QT Test Team | S&A Qualification | 97.33 | 6.11 | Red | Laura Kennedy | RED |
| 1897 | 1.6.4.1.8.5.4.4 | Regression Test | 10d | 2025-02-07 | 2025-02-20 | 1896 |  |  | 2025-01-08 | 2025-01-21 | 10d | 740d |  |  |  | Non-SIT S&A QT Test Team | Non-SIT S&A QT Test Team | S&A Qualification | 99.33 | 6.11 | Red | Laura Kennedy | RED |
| 1898 | 1.6.4.1.8.5.5 | **DIP Onboarding (UIT)** | 37d | 2024-08-05 A | 2024-09-24 |  | 46% | 20d | 2024-08-05 | 2024-09-24 | 37d | 847d |  |  |  | N/A | N/A | S&A Qualification | -594.67 | 5.27 |  | N/A |  |
| 1899 | 1.6.4.1.8.5.5.1 | DIP available for Onboarding | 1d | 2024-08-05 A | 2024-08-05 A | 1885 | 100% |  | 2024-08-05 | 2024-08-05 | 1d |  |  | start no earlier than 2024-08-05 |  | MHHSP, Avanade | MHHSP, Avanade | S&A Qualification |  | 5.27 | Complete | Laura Kennedy | COMPLETE |
| 1900 | 1.6.4.1.8.5.5.2 | Qualification Testing for Non-SIT S&A Participants' environments) Ready to start DIP onboarding (incl. certificates and security compliance) | 15d | 2024-08-06 A | 2024-08-26 A | 1899 | 100% |  | 2024-08-06 | 2024-08-26 | 15d |  |  |  |  | MHHSP, Avanade | MHHSP, Avanade | S&A Qualification |  | 5.27 | Complete | Laura Kennedy | COMPLETE |
| 1901 | 1.6.4.1.8.5.5.3 | Non-SIT S&A QTF Environments Connection Confirmed to UIT Environment | 1d | 2024-08-27 A | 2024-08-27 A | 1900 | 100% |  | 2024-08-27 | 2024-08-27 | 1d |  |  |  |  | Non-SIT S&A QT Test Team | Non-SIT S&A QT Test Team | S&A Qualification |  | 5.27 | Complete | Laura Kennedy | COMPLETE |
| 1902 | 1.6.4.1.8.5.5.4 | DIP UIT Test Stubs | 20d | 2024-08-28 | 2024-09-24 | 1901 |  |  | 2024-08-28 | 2024-09-24 | 20d | 847d |  |  |  | Non-SIT S&A QT Test Team | Non-SIT S&A QT Test Team, Avanade | S&A Qualification | -63.67 | 5.27 | Overdue Start |  | RED |
| 1903 | 1.6.4.1.8.5.6 | **DTN Onboarding** | 95d | 2024-05-20 A | 2024-09-27 |  | 47% | 50.21d | 2024-05-20 | 2024-09-27 | 95d | 844d |  |  | -0 | N/A | N/A | S&A Qualification | -594.67 | 5.27 |  | N/A |  |
| 1904 | 1.6.4.1.8.5.6.1 | DTN Request Raised for Onboarding | 25d | 2024-05-20 A | 2024-06-21 A | 1885FS+10d | 100% |  | 2024-05-20 | 2024-06-21 | 25d |  |  |  |  | Non-SIT S&A QT Test Team | Non-SIT S&A QT Test Team | S&A Qualification |  | 5.27 | Complete | Laura Kennedy | COMPLETE |
| 1905 | 1.6.4.1.8.5.6.2 | Setup, configuration of New Host and Test Flags | 5d | 2024-06-24 A | 2024-06-28 A | 1904 | 100% |  | 2024-06-24 | 2024-06-28 | 5d |  |  |  |  | Electralink | Electralink | S&A Qualification |  | 5.27 | Complete | Laura Kennedy | COMPLETE |
| 1906 | 1.6.4.1.8.5.6.3 | New VPN Connection | 30d | 2024-08-05 A | 2024-09-13 | 1905FS+25d | 10% | 27d | 2024-08-05 | 2024-09-13 | 30d | 844d | 0d |  |  | QT Test Team | QT Test Team | S&A Qualification |  | 5.30 | Overdue | Laura Kennedy | RED |
| 1907 | 1.6.4.1.8.5.6.4 | DTN Test Stubs | 10d | 2024-09-16 | 2024-09-27 | 1906 |  |  | 2024-09-16 | 2024-09-27 | 10d | 844d |  |  |  | Non-SIT S&A QT Test Team | Non-SIT S&A QT Test Team | S&A Qualification | -44.67 | 5.27 | Overdue Start | Laura Kennedy | RED |
| 1908 | 1.6.4.1.8.6 | **Test Data (MPANs, DIP Messages, Settlement, Consumption, Reference)** | 435d | 2024-06-10 A | 2026-02-06 |  | 15% | 371.68d | 2024-06-10 | 2025-12-26 | 299d | 489d |  |  | -0 | N/A | N/A | S&A Qualification | -385.67 | 5.27 |  | N/A |  |
| 1909 | 1.6.4.1.8.6.1 | Sample MPAN Data + Attributes from Suppliers | 15d | 2024-06-10 A | 2024-06-28 A | 1816 | 100% |  | 2024-06-10 | 2024-06-28 | 15d |  |  |  |  | Participants | Participants | S&A Qualification |  | 5.27 | Complete | Laura Kennedy | COMPLETE |
| 1910 | 1.6.4.1.8.6.2 | Test Data Templates and generator tools ready | 30d | 2024-06-24 A | 2024-08-02 A | 1870SS+20d, 1909FF+25d | 100% |  | 2024-06-24 | 2024-08-02 | 30d |  |  |  |  | Non-SIT S&A QT Test Team | Non-SIT S&A QT Test Team | S&A Qualification |  | 5.27 | Complete | Laura Kennedy | COMPLETE |
| 1911 | 1.6.4.1.8.6.3 | **Industry Standing Data (ISD)** | 33d | 2024-07-26 A | 2024-09-10 |  | 6% | 31.17d | 2024-07-26 | 2024-09-10 | 33d | 857d |  |  | -0 | N/A | N/A | S&A Qualification | -594.67 | 5.27 |  | N/A |  |
| 1912 | 1.6.4.1.8.6.3.1 | Dependant on Receiving ISD Agreed Source Data from Helix | 1d | 2024-07-26 A | 2024-07-26 A |  | 100% |  | 2024-07-26 | 2024-07-26 | 1d |  |  | start no earlier than 2024-07-26 |  | Helix | Helix | S&A Qualification |  | 5.27 | Complete | Laura Kennedy | COMPLETE |
| 1913 | 1.6.4.1.8.6.3.2 | First View of Migrated ISD Data | 1d | 2024-08-19 | 2024-08-19 | 1912 |  |  | 2024-08-19 | 2024-08-19 | 1d | 857d | 0d | start no earlier than 2024-08-19 |  |  |  | S&A Qualification | -72.67 | 5.28 | Overdue Start | Laura Kennedy | RED |
| 1914 | 1.6.4.1.8.6.3.3 | Final Cycle 3 Migrated ISD Data | 1d | 2024-08-20 | 2024-08-20 | 1913 |  |  | 2024-08-20 | 2024-08-20 | 1d | 857d | 0d |  |  |  |  | S&A Qualification | -71.67 | 5.28 | Overdue Start | Laura Kennedy | RED |
| 1915 | 1.6.4.1.8.6.3.4 | Create ISD Template inc. DIP ID | 5d | 2024-08-21 | 2024-08-27 | 1914 |  |  | 2024-08-21 | 2024-08-27 | 5d | 857d | 0d |  |  | Non-SIT S&A QT Test Team | Non-SIT S&A QT Test Team | S&A Qualification | -70.67 | 5.27 | Overdue Start | Laura Kennedy | RED |
| 1916 | 1.6.4.1.8.6.3.5 | Publish Qualification ISD | 10d | 2024-08-28 | 2024-09-10 | 1915 |  |  | 2024-08-28 | 2024-09-10 | 10d | 857d |  |  |  | Non-SIT S&A QT Test Team | Non-SIT S&A QT Test Team | S&A Qualification | -63.67 | 5.27 | Overdue Start | Laura Kennedy | RED |

Notes:
- 1895: Team confirming when this should take place, expected that the forecast is too late.
- 1896: Team confirming when this should take place, expected that the forecast is too late.
- 1897: Team confirming when this should take place, expected that the forecast is too late.
- 1899: Action: 3/7: Link into UIT ENV
- 1910: Action: 6/8/24: To be split into 2 tasks - jordan awaiting update. Successor?
- 1913: Action: 6/8/24: Will have to reflect the start of the new maintenence window

| ID | WBS | Task | Type | Duration | Start | Finish | Predecessors | Complete | Remaining | Baseline start | Baseline finish | Baseline duration | Total slack | Free slack | Responsible | Involved | Text9 | Task Status | Update Version | MHHS Resource Name | Sched Status | RAG | Milestone ID | Text29 |
| --- | --- | --- | --- | --- | --- | --- | --- | --- | --- | --- | --- | --- | --- | --- | --- | --- | --- | --- | --- | --- | --- | --- | --- | --- |
| 1917 | 1.6.4.1.8.6.4 | **Wave 1 Test Data** |  | 46d | 2025-06-16 | 2025-08-18 |  |  |  | 2025-06-16 | 2025-08-18 | 46d | 10d |  | N/A | N/A | S&A Qualification | -596.67 | 6.1 | N/A |  |  |  |  |
| 1918 | 1.6.4.1.8.6.4.1 | Test Data Request + Templates Completed |  | 16d | 2025-06-16 | 2025-07-07 | 1961 |  |  | 2025-06-16 | 2025-07-07 | 16d | 10d | 0d | Participants | Participants | S&A Qualification | 228.33 | 6.1 | Laura Kennedy | Green | GREEN |  |  |
| 1919 | 1.6.4.1.8.6.4.2 | Test Data Generated |  | 10d | 2025-07-08 | 2025-07-21 | 1918 |  |  | 2025-07-08 | 2025-07-21 | 10d | 10d | 0d | Non-SIT S&A QT Test Team | Non-SIT S&A QT Test Team | S&A Qualification | 250.33 | 6.1 | Laura Kennedy | Green | GREEN |  |  |
| 1920 | 1.6.4.1.8.6.4.3 | Test Data Loaded into QP Systems |  | 20d | 2025-07-22 | 2025-08-18 | 1919 |  |  | 2025-07-22 | 2025-08-18 | 20d | 10d | 4d | Participants | Participants | S&A Qualification | 264.33 | 6.1 | Laura Kennedy | Green | GREEN |  |  |
| 1921 | 1.6.4.1.8.6.4.4 | Test Data Loaded into QTF + ADO |  | 19d | 2025-07-22 | 2025-08-15 | 1919 |  |  | 2025-07-22 | 2025-08-15 | 20d | 11d | 5d | Non-SIT S&A QT Test Team | Non-SIT S&A QT Test Team | S&A Qualification | 264.33 | 6.1 | Laura Kennedy | Green | GREEN |  |  |
| 1922 | 1.6.4.1.8.6.5 | **Wave 2 Test Data** |  | 42d | 2025-08-18 | 2025-10-14 |  |  |  | 2025-08-18 | 2025-10-14 | 42d | 9d |  | N/A | N/A | S&A Qualification | -596.67 | 6.1 | N/A |  |  |  |  |
| 1923 | 1.6.4.1.8.6.5.1 | Test Data Request + Templates Completed |  | 16d | 2025-08-18 | 2025-09-08 | 1991 |  |  | 2025-08-18 | 2025-09-08 | 16d | 9d | 0d | Participants | Participants | S&A Qualification | 291.33 | 6.1 | Laura Kennedy | Green | GREEN |  |  |
| 1924 | 1.6.4.1.8.6.5.2 | Test Data Generated |  | 10d | 2025-09-09 | 2025-09-22 | 1923 |  |  | 2025-09-09 | 2025-09-22 | 10d | 9d | 0d | Non-SIT S&A QT Test Team | Non-SIT S&A QT Test Team | S&A Qualification | 313.33 | 6.1 | Laura Kennedy | Green | GREEN |  |  |
| 1925 | 1.6.4.1.8.6.5.3 | Test Data Loaded into QP Systems |  | 16d | 2025-09-23 | 2025-10-14 | 1924 |  |  | 2025-09-23 | 2025-10-14 | 16d | 9d | 3d | Participants | Participants | S&A Qualification | 327.33 | 6.1 | Laura Kennedy | Green | GREEN |  |  |
| 1926 | 1.6.4.1.8.6.5.4 | Test Data Loaded into QTF + ADO |  | 16d | 2025-09-23 | 2025-10-14 | 1924 |  |  | 2025-09-23 | 2025-10-14 | 16d | 9d | 3d | Non-SIT S&A QT Test Team | Non-SIT S&A QT Test Team | S&A Qualification | 327.33 | 6.1 | Laura Kennedy | Green | GREEN |  |  |
| 1927 | 1.6.4.1.8.6.6 | **Wave 3 Test Data** |  | 45d | 2025-10-20 | 2025-12-19 |  |  |  | 2025-10-20 | 2025-12-19 | 45d | 0d |  | N/A | N/A | S&A Qualification | -596.67 | 6.1 | N/A |  |  |  |  |
| 1928 | 1.6.4.1.8.6.6.1 | Test Data Request + Templates Completed |  | 15d | 2025-10-20 | 2025-11-07 | 2021 |  |  | 2025-10-20 | 2025-11-07 | 15d | 0d |  | Participants | Participants | S&A Qualification | 354.33 | 6.1 | Laura Kennedy | Green | GREEN |  |  |
| 1929 | 1.6.4.1.8.6.6.2 | Test Data Generated |  | 10d | 2025-11-10 | 2025-11-21 | 1928 |  |  | 2025-11-10 | 2025-11-21 | 10d | 0d |  | Non-SIT S&A QT Test Team | Non-SIT S&A QT Test Team | S&A Qualification | 375.33 | 6.1 | Laura Kennedy | Green | GREEN |  |  |
| 1930 | 1.6.4.1.8.6.6.3 | Test Data Loaded into QP Systems |  | 20d | 2025-11-24 | 2025-12-19 | 1929 |  |  | 2025-11-24 | 2025-12-19 | 20d | 0d |  | Participants | Participants | S&A Qualification | 389.33 | 6.1 | Laura Kennedy | Green | GREEN |  |  |
| 1931 | 1.6.4.1.8.6.6.4 | Test Data Loaded into QTF + ADO |  | 20d | 2025-11-24 | 2025-12-19 | 1929 |  |  | 2025-11-24 | 2025-12-19 | 20d | 0d |  | Non-SIT S&A QT Test Team | Non-SIT S&A QT Test Team | S&A Qualification | 389.33 | 6.1 | Laura Kennedy | Green | GREEN |  |  |
| 1932 | 1.6.4.1.8.6.7 | **Wave 4 Test Data** |  | 45d | 2025-12-08 | 2026-02-06 |  |  |  | 2025-12-08 | 2026-02-06 | 45d | 19d |  | N/A | N/A | S&A Qualification | -596.67 | 6.1 | N/A |  |  |  |  |
| 1933 | 1.6.4.1.8.6.7.1 | Test Data Request + Templates Completed |  | 15d | 2025-12-08 | 2025-12-26 | 2051 |  |  | 2025-12-08 | 2025-12-26 | 15d | 19d | 0d | Participants | Participants | S&A Qualification | 403.33 | 6.1 | Laura Kennedy | Green | GREEN |  |  |
| 1934 | 1.6.4.1.8.6.7.2 | Test Data Generated |  | 10d | 2025-12-29 | 2026-01-09 | 1933 |  |  | 2025-12-29 | 2026-01-09 | 10d | 19d | 0d | Non-SIT S&A QT Test Team | Non-SIT S&A QT Test Team | S&A Qualification | 424.33 | 6.1 | Laura Kennedy | Green | GREEN |  |  |
| 1935 | 1.6.4.1.8.6.7.3 | Test Data Loaded into QP Systems |  | 20d | 2026-01-12 | 2026-02-06 | 1934 |  |  | 2026-01-12 | 2026-02-06 | 20d | 19d | 15d | Participants | Participants | S&A Qualification | 438.33 | 6.1 | Laura Kennedy | Green | GREEN |  |  |
| 1936 | 1.6.4.1.8.6.7.4 | Test Data Loaded into QTF + ADO |  | 20d | 2026-01-12 | 2026-02-06 | 1934 |  |  | 2026-01-12 | 2026-02-06 | 20d | 19d | 15d | Non-SIT S&A QT Test Team | Non-SIT S&A QT Test Team | S&A Qualification | 438.33 | 6.1 | Laura Kennedy | Green | GREEN |  |  |
| 1937 | 1.6.4.1.8.7 | **Governance** |  | 130d | 2024-07-01 A | 2024-12-27 |  | 29% | 92.67d | 2024-07-01 | 2024-12-27 | 130d | 779d |  | N/A | N/A | S&A Qualification | -594.67 | 5.27 | N/A |  |  |  |  |
| 1938 | 1.6.4.1.8.7.1 | Onboarding Strategy and Develop Training Requirements & Materials Inc. Day in the Life |  | 65d | 2024-07-01 A | 2024-09-27 | 1864 | 43% | 37d | 2024-07-01 | 2024-09-27 | 65d | 844d | 0d | Non-SIT S&A QT Test Team | Non-SIT S&A QT Test Team | S&A Qualification |  | 5.27 | Laura Kennedy | Overdue | RED |  |  |
| 1939 | 1.6.4.1.8.7.2 | Design Approach & Set-Up ADO Tool for Test & Defect Management Tool |  | 45d | 2024-07-01 A | 2024-08-30 | 1938SS | 62% | 17d | 2024-07-01 | 2024-08-30 | 45d | 216d | 0d | Non-SIT S&A QT Test Team | Non-SIT S&A QT Test Team | S&A Qualification |  | 5.27 | Laura Kennedy | Overdue | RED |  |  |
| 1940 | 1.6.4.1.8.7.3 | Knowledge Transfer, Training, Demonstrations, Documentation, Governance |  | 85d | 2024-09-02 | 2024-12-27 | 1938SS+45d |  |  | 2024-09-02 | 2024-12-27 | 85d | 176d | 0d | Non-SIT S&A QT Test Team | Non-SIT S&A QT Test Team | S&A Qualification | -58.67 | 5.27 | Laura Kennedy | Overdue Start | GREEN |  |  |
| 1941 | 1.6.4.1.8.8 | Qualification Testing Wave Readiness Confirmed | milestone | 0d | 2024-12-27 | 2024-12-27 | 1940 |  |  | 2024-12-27 | 2024-12-27 | 0d | 176d | 171d | Non-SIT S&A QT Test Team | Non-SIT S&A QT Test Team, Code Bodies | S&A Qualification | 57.71 | 5.25 | Laura Kennedy | Green | GREEN | T3-QU-0117 | QAG |

Notes:
- 1918: Team confirming when this should take place, expected that the forecast is too late.
- 1919: Team confirming when this should take place, expected that the forecast is too late.

| ID | WBS | Task | Type | Duration | Start | Finish | Predecessors | Complete | Baseline start | Baseline finish | Baseline duration | Total slack | Free slack | Constraint | Baseline cost | Responsible | Involved | Text9 | Task Status | Update Version | MHHS Resource Name | Sched Status | RAG | Milestone ID | Text29 |
| --- | --- | --- | --- | --- | --- | --- | --- | --- | --- | --- | --- | --- | --- | --- | --- | --- | --- | --- | --- | --- | --- | --- | --- | --- | --- |
| 1942 | 1.6.4.1.9 | **Wave Allocation** |  | 129d | 2024-01-02 A | 2024-06-28 A |  | 100% | 2024-01-02 | 2024-06-28 | 128d |  |  |  | -0 | N/A | N/A | S&A Qualification | -133.67 | 5.24 | N/A |  |  |  |  |
| 1943 | 1.6.4.1.9.1 | Draft Pre-Qualification Submission (PQS) document |  | 20d | 2024-01-02 A | 2024-01-29 A |  | 100% | 2024-01-02 | 2024-01-29 | 20d |  |  | finish no earlier than 2024-01-26 |  | Code Bodies | Code Bodies | S&A Qualification |  | 5.24 | Laura Kennedy | Complete | COMPLETE |  |  |
| 1944 | 1.6.4.1.9.2 | Publish PQS document |  | 1d | 2024-01-31 A | 2024-01-31 A |  | 100% | 2024-01-31 | 2024-01-31 | 1d |  |  | start no earlier than 2024-01-31 |  | Code Bodies | Code Bodies | S&A Qualification |  | 5.24 | Laura Kennedy | Complete | COMPLETE |  |  |
| 1945 | 1.6.4.1.9.3 | PQS Submission window |  | 60d | 2024-02-05 A | 2024-04-26 A |  | 100% | 2024-02-05 | 2024-04-26 | 60d |  |  | start no earlier than 2024-02-05 |  | Participants | Participants | S&A Qualification |  | 5.24 | Laura Kennedy | Complete | COMPLETE |  |  |
| 1946 | 1.6.4.1.9.4 | Pre-Qualification Submission and PIT Test Plan Deadline for Submission​ | milestone | 0d | 2024-04-26 A | 2024-04-26 A | 1945 | 100% | 2024-04-26 | 2024-04-26 | 0d |  |  |  |  | Participants | Participants | S&A Qualification |  | 5.25 | Laura Kennedy | Complete | COMPLETE | T3-QU-0118 | QAG |
| 1947 | 1.6.4.1.9.5 | PQS Review by Code Bodies |  | 25d | 2024-04-29 A | 2024-05-31 A | 1945, 1946 | 100% | 2024-04-29 | 2024-05-31 | 25d |  |  |  |  | Code Bodies | Code Bodies | S&A Qualification |  | 5.24 | Laura Kennedy | Complete | COMPLETE |  |  |
| 1948 | 1.6.4.1.9.6 | Draft Wave Allocations |  | 15d | 2024-06-03 A | 2024-06-21 A | 1947 | 100% | 2024-06-03 | 2024-06-21 | 15d |  |  |  |  | Code Bodies | Code Bodies | S&A Qualification |  | 5.24 | Laura Kennedy | Complete | COMPLETE |  |  |
| 1949 | 1.6.4.1.9.7 | Confirmation of participant Qualification Wave allocation | milestone | 0d | 2024-06-28 A | 2024-06-28 A | 1948FS+5d | 100% | 2024-06-28 | 2024-06-28 | 0d |  |  |  |  | Code Bodies | Code Bodies | S&A Qualification |  | 5.28 | Laura Kennedy | Complete | COMPLETE | T3-QU-0012 | QAG |
| 1950 | 1.6.4.2 | **Qualification Wave 1** |  | 245d | 2025-05-05 | 2026-04-10 |  |  | 2025-03-24 | 2026-04-10 | 229d | 5d |  |  | -0 | N/A | N/A | S&A Qualification | -133.67 | 6.1 | N/A |  |  |  |  |
| 1951 | 1.6.4.2.1 | **Qualification Wave 1 QAD Prep** |  | 80d | 2025-05-05 | 2025-08-22 |  |  | 2025-03-24 | 2025-07-11 | 80d | 6d |  |  | -0 | N/A | N/A | S&A Qualification | -152.67 | 6.1 | N/A |  |  |  |  |
| 1952 | 1.6.4.2.1.1 | Initial QAD Submission window opens | milestone | 0d | 2025-05-05 | 2025-05-05 | 1949, 1768FS+11d |  | 2025-05-05 | 2025-05-05 | 0d | 6d | 0d | start no earlier than 2025-03-24 |  | Participants | Participants | S&A Qualification | 186.71 | 6.1 | Laura Kennedy | Green | GREEN |  |  |
| 1953 | 1.6.4.2.1.2 | Qualification Wave 1 Participants Submit Initial QAD |  | 50d | 2025-05-05 | 2025-07-11 | 1952FS-1d |  | 2025-05-05 | 2025-07-11 | 50d | 6d | 0d |  |  | Participants | Participants | S&A Qualification | 186.33 | 6.1 | Laura Kennedy | Green | GREEN |  |  |
| 1954 | 1.6.4.2.1.3 | Qualification Wave 1 Participants have submitted their initial QAD | milestone | 0d | 2025-07-14 | 2025-07-14 | 1953FS+1d |  | 2025-07-14 | 2025-07-14 | 0d | 6d | 0d |  |  | Participants | Participants | S&A Qualification | 256.71 | 6.1 | Laura Kennedy | Green | GREEN | T3-QU-0094 | QAG |
| 1955 | 1.6.4.2.1.4 | Code Bodies review of Wave 1 Participants Initial QAD |  | 30d | 2025-07-14 | 2025-08-22 | 1953FS-1d, 1954FS-1d |  | 2025-07-14 | 2025-08-22 | 30d | 6d | 0d |  |  | Code Bodies | Code Bodies | S&A Qualification | 256.33 | 6.1 | Laura Kennedy | Green | GREEN |  |  |
| 1956 | 1.6.4.2.1.5 | Completion of Code Bodies review of Initial QAD | milestone | 0d | 2025-08-22 | 2025-08-22 | 1955 |  | 2025-08-22 | 2025-08-22 | 0d | 6d | 0d |  |  | Code Bodies | Code Bodies | S&A Qualification | 295.71 | 6.1 | Laura Kennedy | Green | GREEN |  |  |
| 1957 | 1.6.4.2.2 | **Qualification Wave 1 Test Prep** |  | 60d | 2025-05-26 | 2025-08-15 |  |  | 2025-04-14 | 2025-07-04 | 60d | 11d |  |  | -0 | N/A | N/A | S&A Qualification | -555.67 | 6.11 | N/A |  |  |  |  |
| 1958 | 1.6.4.2.2.1 | Confirmation from Qualification Wave 1 Participants that DIP onboarding has commenced | milestone | 0d | 2025-05-26 | 2025-05-26 |  |  | 2025-05-26 | 2025-05-26 | 0d | 31d | 0d | start no earlier than 2025-05-26 |  | Participants | Participants | S&A Qualification | 207.33 | 6.11 | Laura Kennedy | Green | GREEN | T3-QU-0017 | QAG |
| 1959 | 1.6.4.2.2.2 | Qualification Wave 1 Participants DIP Onboarding Window |  | 35d | 2025-05-26 | 2025-07-11 | 1958 |  | 2025-05-26 | 2025-07-11 | 35d | 31d | 0d |  |  | Participants | Participants | S&A Qualification | 207.33 | 6.11 | Laura Kennedy | Green | GREEN |  |  |
| 1960 | 1.6.4.2.2.3 | Confirmation from Qualification Wave 1 Participants that DIP onboarding has completed | milestone | 0d | 2025-07-11 | 2025-07-11 | 1959 |  | 2025-07-11 | 2025-07-11 | 0d | 31d | 25d |  |  | Participants | Participants | S&A Qualification | 253.71 | 6.11 | Laura Kennedy | Green | GREEN |  |  |
| 1961 | 1.6.4.2.2.4 | Qualification Wave 1 Participants' to provide status of PIT completion and submit QT Test Plan | milestone | 0d | 2025-06-16 | 2025-06-16 |  |  | 2025-06-16 | 2025-06-16 | 0d | 10d | 0d | start no earlier than 2025-06-16 |  | Participants | Participants | S&A Qualification | 228.33 | 6.11 | Laura Kennedy | Green | GREEN | T3-QU-0095 | QAG |
| 1962 | 1.6.4.2.2.5 | Review of Participants' PIT Status and QT Test Plan |  | 15d | 2025-06-16 | 2025-07-04 | 1961 |  | 2025-06-16 | 2025-07-04 | 15d | 36d | 0d |  |  | Code Bodies, Non-SIT S&A QT Test Team | Code Bodies, Non-SIT S&A QT Test Team | S&A Qualification | 228.33 | 6.11 | Laura Kennedy | Green | GREEN |  |  |
| 1963 | 1.6.4.2.2.6 | Qualification Test Plans for Wave 1 Participants approved | milestone | 0d | 2025-07-04 | 2025-07-04 | 1962 |  | 2025-07-04 | 2025-07-04 | 0d | 36d | 30d |  |  | Non-SIT S&A QT Test Team | Non-SIT S&A QT Test Team | S&A Qualification | 246.71 | 6.11 | Laura Kennedy | Green | GREEN | T3-QU-0016 | QAG |
| 1964 | 1.6.4.2.2.7 | Qualification Wave 1 Participants have submitted PIT Test Completion Report and evidence for QT Entry | milestone | 0d | 2025-07-14 | 2025-07-14 |  |  | 2025-07-14 | 2025-07-14 | 0d | 6d | 0d | start no earlier than 2025-07-14 |  | Participants | Participants | S&A Qualification | 256.33 | 6.11 | Laura Kennedy | Green | GREEN | T3-QU-0096 | QAG |
| 1965 | 1.6.4.2.2.8 | Review of Participants PIT Test Completion Report |  | 25d | 2025-07-14 | 2025-08-15 | 1964 |  | 2025-07-14 | 2025-08-15 | 25d | 6d | 0d |  |  | Code Bodies, Non-SIT S&A QT Test Team | Code Bodies, Non-SIT S&A QT Test Team | S&A Qualification | 256.33 | 6.11 | Laura Kennedy | Green | GREEN |  |  |
| 1966 | 1.6.4.2.2.9 | Onboarding to QTF & ADO |  | 25d | 2025-07-14 | 2025-08-15 | 1965SS, 1883 |  | 2025-07-14 | 2025-08-15 | 25d | 11d | 6d |  |  | Code Bodies, Non-SIT S&A QT Test Team | Code Bodies, Non-SIT S&A QT Test Team | S&A Qualification | 256.33 | 6.11 | Laura Kennedy | Green | GREEN |  |  |

Notes:
- 1952: 29/10/24 - Dates updated to reflect CR055.
- 1958: 29/10/24 - Dates updated to reflect CR055.
- 1959: 29/10/24 - Dates updated to reflect CR055.
- 1960: 29/10/24 - Dates updated to reflect CR055.
- 1961: 29/10/24 - Dates updated to reflect CR055.
- 1962: 29/10/24 - Dates updated to reflect CR055.
- 1963: 29/10/24 - Dates updated to reflect CR055.
- 1964: 29/10/24 - Dates updated to reflect CR055.

| ID | WBS | Task | Type | Duration | Start | Finish | Predecessors | Baseline start | Baseline finish | Baseline duration | Total slack | Free slack | Constraint | Baseline cost | Responsible | Involved | Text9 | Task Status | Update Version | MHHS Resource Name | Sched Status | RAG | Milestone ID | Text29 |
| --- | --- | --- | --- | --- | --- | --- | --- | --- | --- | --- | --- | --- | --- | --- | --- | --- | --- | --- | --- | --- | --- | --- | --- | --- |
| 1967 | 1.6.4.2.3 | **Qualification Wave 1 QT Execution** |  | 100d | 2025-08-18 | 2026-01-02 |  | 2025-07-07 | 2026-01-02 | 100d | 6d |  |  | -0 | N/A | N/A | S&A Qualification | -152.67 | 6.1 | N/A |  |  |  |  |
| 1968 | 1.6.4.2.3.1 | Review Entry Criteria Evidence for each Wave 1 Participant |  | 5d | 2025-08-18 | 2025-08-22 | 1956FF, 1960, 1963, 1965 | 2025-08-18 | 2025-08-22 | 5d | 6d | 0d |  |  | Non-SIT S&A QT Test Team | Non-SIT S&A QT Test Team | S&A Qualification | 291.33 | 6.1 | Laura Kennedy | Green | GREEN |  |  |
| 1969 | 1.6.4.2.3.2 | Qualification Wave 1 Participant Test Readiness Confirmed | milestone | 0d | 2025-08-22 | 2025-08-22 | 1955, 1956, 1968FF, 1920, 1921 | 2025-08-22 | 2025-08-22 | 0d | 6d | 1d |  |  | Non-SIT S&A QT Test Team | Non-SIT S&A QT Test Team | S&A Qualification | 295.71 | 6.1 | Laura Kennedy | Green | GREEN | T3-QU-0027 | QAG |
| 1970 | 1.6.4.2.3.3 | Qualification Wave 1 QT Execution Start | milestone | 0d | 2025-08-25 | 2025-08-25 | 1969, 1941, 1966, 1377FS+6d | 2025-08-25 | 2025-08-25 | 0d | 5d | 0d | start no earlier than 2025-07-14 |  | Participants | Participants | S&A Qualification | 298.71 | 6.1 | Laura Kennedy | Green | GREEN | T3-QU-0028 | QAG |
| 1971 | 1.6.4.2.3.4 | Qualification Wave 1 QT Execution Window |  | 95d | 2025-08-25 | 2026-01-02 | 1970FS-1d | 2025-08-25 | 2026-01-02 | 95d | 10d | 0d |  |  | Participants | Participants | S&A Qualification | 298.33 | 6.1 | Laura Kennedy | Green | GREEN |  |  |
| 1972 | 1.6.4.2.3.5 | Qualification Wave 1 QT Projected Execution End | milestone | 0d | 2026-01-02 | 2026-01-02 | 1971 | 2026-01-02 | 2026-01-02 | 0d | 10d | 5d |  |  | Participants | Participants | S&A Qualification | 428.71 | 6.1 | Laura Kennedy | Green | GREEN | T3-QU-0054 | QAG |
| 1973 | 1.6.4.2.4 | **Qualification Wave 1 Exit** |  | 165d | 2025-08-25 | 2026-04-10 |  | 2025-08-25 | 2026-04-10 | 149d? | 5d |  |  | -0 | N/A | N/A | S&A Qualification | -152.67 | 6.1 | N/A |  |  |  |  |
| 1974 | 1.6.4.2.4.1 | Final QAD Submission window opens | milestone | 0d | 2025-08-25 | 2025-08-25 | 1970 | 2025-08-25 | 2025-08-25 | 0d | 5d | 0d |  |  | Participants | Participants | S&A Qualification | 298.71 | 6.1 | Laura Kennedy | Green | GREEN |  |  |
| 1975 | 1.6.4.2.4.2 | Qualification Wave 1 Participants submit their Final QAD |  | 100d | 2025-08-25 | 2026-01-09 | 1974FS-1d | 2025-08-25 | 2026-01-09 | 100d | 5d | 0d |  |  | Participants | Participants | S&A Qualification | 298.33 | 6.1 | Laura Kennedy | Green | GREEN |  |  |
| 1976 | 1.6.4.2.4.3 | Qualification Wave 1 Participants have submitted their final QAD | milestone | 0d | 2026-01-09 | 2026-01-09 | 1975, 1972 | 2026-01-09 | 2026-01-09 | 0d | 5d | 0d |  |  | Participants | Participants | S&A Qualification | 435.71 | 6.1 | Laura Kennedy | Green | GREEN | T3-QU-0097 | QAG |
| 1977 | 1.6.4.2.4.4 | Completion of Code Bodies review of Final QAD |  | 35d | 2026-01-12 | 2026-02-27 | 1975, 1976 | 2026-01-12 | 2026-02-27 | 20d | 5d | 0d |  |  | Code Bodies | Code Bodies | S&A Qualification | 438.33 | 6.1 | Laura Kennedy | Green | GREEN |  |  |
| 1978 | 1.6.4.2.4.5 | QAD Sign Off deadline |  | 1d | 2026-03-13 | 2026-03-13 | 1977FS+9d | 2026-03-13 | 2026-03-13 | 1d | 5d | 0d |  |  | Participants | Participants | S&A Qualification | 498.33 | 6.1 | Laura Kennedy | Green | GREEN |  |  |
| 1979 | 1.6.4.2.4.6 | Qualification Wave 1 Participants Qualification approved by BSC PAB and REC Manager | milestone | 0d | 2026-04-10 | 2026-04-10 | 1978FS+20d | 2026-04-10 | 2026-04-10 | 0d | 5d | 0d |  |  | Code Bodies | Code Bodies | S&A Qualification | 526.71 | 6.1 | Laura Kennedy | Green | GREEN | T2-QU-0150 | QAG |
| 1980 | 1.6.4.3 | **Qualification Wave 2** |  | 253d | 2025-06-09 | 2026-05-27 |  | 2025-06-09 | 2026-05-27 | 249d | 6d |  |  | -0 | N/A | N/A | S&A Qualification | -133.67 | 6.1 | N/A |  |  |  |  |
| 1981 | 1.6.4.3.1 | **Qualification Wave 2 QAD Prep** |  | 95d | 2025-06-09 | 2025-10-17 |  | 2025-06-09 | 2025-10-17 | 96d | 6d |  |  | -0 | N/A | N/A | S&A Qualification | -154.67 | 6.1 | N/A |  |  |  |  |
| 1982 | 1.6.4.3.1.1 | Initial QAD Submission window opens | milestone | 0d | 2025-06-09 | 2025-06-09 | 1769FS+151d | 2025-06-09 | 2025-06-09 | 0d | 6d | 0d |  |  | Participants | Participants | S&A Qualification | 221.71 | 6.1 | Laura Kennedy | Green | GREEN |  |  |
| 1983 | 1.6.4.3.1.2 | Qualification Wave 2 Participants Submit Initial QAD |  | 70d | 2025-06-09 | 2025-09-12 | 1982FS-1d | 2025-06-09 | 2025-09-12 | 70d | 6d | 0d |  |  | Participants | Participants | S&A Qualification | 221.33 | 6.1 | Laura Kennedy | Green | GREEN |  |  |
| 1984 | 1.6.4.3.1.3 | Qualification Wave 2 Participants have submitted their initial QAD | milestone | 0d | 2025-09-12 | 2025-09-12 | 1983 | 2025-09-12 | 2025-09-12 | 0d | 6d | 0d |  |  | Participants | Participants | S&A Qualification | 316.71 | 6.1 | Laura Kennedy | Green | GREEN | T3-QU-0098 | QAG |
| 1985 | 1.6.4.3.1.4 | Code Bodies review of Wave 2 Participants' Initial QAD |  | 25d | 2025-09-15 | 2025-10-17 | 1984 | 2025-09-15 | 2025-10-17 | 26d | 6d | 0d |  |  | Code Bodies | Code Bodies | S&A Qualification | 319.33 | 6.1 | Laura Kennedy | Green | GREEN |  |  |
| 1986 | 1.6.4.3.1.5 | Completion of Code Bodies review of Initial QAD | milestone | 0d | 2025-10-17 | 2025-10-17 | 1985 | 2025-10-17 | 2025-10-17 | 0d | 6d | 0d |  |  | Code Bodies | Code Bodies | S&A Qualification | 351.71 | 6.1 | Laura Kennedy | Green | GREEN |  |  |
| 1987 | 1.6.4.3.2 | **Qualification Wave 2 Test Prep** |  | 60d | 2025-07-21 | 2025-10-10 |  | 2025-06-09 | 2025-08-29 | 60d | 12d |  |  | -0 | N/A | N/A | S&A Qualification | -555.67 | 6.11 | N/A |  |  |  |  |
| 1988 | 1.6.4.3.2.1 | Confirmation from Qualification Wave 2 Participants that DIP Onboarding has commenced | milestone | 0d | 2025-07-21 | 2025-07-21 |  | 2025-07-21 | 2025-07-21 | 0d | 31d | 0d | start no earlier than 2025-07-21 |  | Participants | Participants | S&A Qualification | 263.33 | 6.11 | Laura Kennedy | Green | GREEN | T3-QU-0021 | QAG |
| 1989 | 1.6.4.3.2.2 | Qualification Wave 2 Participants DIP Onboarding Window |  | 35d | 2025-07-21 | 2025-09-05 | 1988 | 2025-07-21 | 2025-09-05 | 40d | 31d | 0d |  |  | Participants | Participants | S&A Qualification | 263.33 | 6.11 | Laura Kennedy | Green | GREEN |  |  |
| 1990 | 1.6.4.3.2.3 | Confirmation from Qualificiation Wave 2 Participants that DIP onboarding has completed | milestone | 0d | 2025-09-05 | 2025-09-05 | 1989 | 2025-09-05 | 2025-09-05 | 0d | 31d | 25d |  |  | Participants | Participants | S&A Qualification | 309.71 | 6.11 | Laura Kennedy | Green | GREEN |  |  |
| 1991 | 1.6.4.3.2.4 | Qualification Wave 2 Participants' to provide status of PIT completion and submit QT Test Plan | milestone | 0d | 2025-08-18 | 2025-08-18 |  | 2025-08-18 | 2025-08-18 | 0d | 9d | 0d | start no earlier than 2025-08-18 |  | Participants | Participants | S&A Qualification | 291.33 | 6.11 | Laura Kennedy | Green | GREEN | T3-QU-0099 | QAG |
| 1992 | 1.6.4.3.2.5 | Review of Participants' PIT Status and QT Test Plan |  | 15d | 2025-08-18 | 2025-09-05 | 1991 | 2025-08-18 | 2025-09-05 | 15d | 31d | 0d | start no earlier than 2025-07-07 |  | Code Bodies, Non-SIT S&A QT Test Team | Code Bodies, Non-SIT S&A QT Test Team | S&A Qualification | 291.33 | 6.11 | Laura Kennedy | Green | GREEN |  |  |
| 1993 | 1.6.4.3.2.6 | Qualification Test Plans for Wave 2 Participants approved | milestone | 0d | 2025-09-05 | 2025-09-05 | 1992 | 2025-09-05 | 2025-09-05 | 0d | 31d | 25d | start no earlier than 2025-07-25 |  | Non-SIT S&A QT Test Team | Non-SIT S&A QT Test Team | S&A Qualification | 309.71 | 6.11 | Laura Kennedy | Green | GREEN | T3-QU-0020 | QAG |
| 1994 | 1.6.4.3.2.7 | Qualification Wave 2 Participants have submitted PIT Test Completion Report and evidence for QT entry | milestone | 0d | 2025-09-08 | 2025-09-08 |  | 2025-09-08 | 2025-09-08 | 0d | 6d | 0d | start no earlier than 2025-09-08 |  | Participants | Participants | S&A Qualification | 312.33 | 6.11 | Laura Kennedy | Green | GREEN | T3-QU-0100 | QAG |
| 1995 | 1.6.4.3.2.8 | Review of Participants' PIT Test Completion Report |  | 25d | 2025-09-08 | 2025-10-10 | 1994 | 2025-09-08 | 2025-10-10 | 25d | 6d | 0d |  |  | Code Bodies, Non-SIT S&A QT Test Team | Code Bodies, Non-SIT S&A QT Test Team | S&A Qualification | 312.33 | 6.11 | Laura Kennedy | Green | GREEN |  |  |
| 1996 | 1.6.4.3.2.9 | Onboarding to QTF & ADO |  | 25d | 2025-09-08 | 2025-10-10 | 1995SS | 2025-09-08 | 2025-10-10 | 25d | 12d | 6d |  |  | Code Bodies, Non-SIT S&A QT Test Team | Code Bodies, Non-SIT S&A QT Test Team | S&A Qualification | 312.33 | 6.11 | Laura Kennedy | Green | GREEN |  |  |

Notes:
- 1970: 29/10/24 - Dates updated to reflect CR055.
- 1988: 29/10/24 - Dates updated to reflect CR055.
- 1989: 29/10/24 - Dates updated to reflect CR055.
- 1990: 29/10/24 - Dates updated to reflect CR055.
- 1991: 29/10/24 - Dates updated to reflect CR055.
- 1992: 29/10/24 - Dates updated to reflect CR055.
- 1993: 29/10/24 - Dates updated to reflect CR055.
- 1994: 29/10/24 - Dates updated to reflect CR055.
- 1995: 29/10/24 - Dates updated to reflect CR055.
- 1996: 29/10/24 - Dates updated to reflect CR055.

| ID | WBS | Task | Type | Duration | Start | Finish | Predecessors | Baseline start | Baseline finish | Baseline duration | Total slack | Free slack | Constraint | Baseline cost | Responsible | Involved | Text9 | Task Status | Update Version | MHHS Resource Name | Sched Status | RAG | Milestone ID | Text29 |
| --- | --- | --- | --- | --- | --- | --- | --- | --- | --- | --- | --- | --- | --- | --- | --- | --- | --- | --- | --- | --- | --- | --- | --- | --- |
| 1997 | 1.6.4.3.3 | **Qualification Wave 2 QT Execution** |  | 100d | 2025-10-13 | 2026-02-27 |  | 2025-10-13 | 2026-02-27 | 99d | 6d |  |  | -0 | N/A | N/A | S&A Qualification | -154.67 | 6.1 | N/A |  |  |  |  |
| 1998 | 1.6.4.3.3.1 | Review Entry Criteria Evidence for each Wave 2 Participant |  | 5d | 2025-10-13 | 2025-10-17 | 1986FF, 1990, 1993, 1995 | 2025-10-13 | 2025-10-17 | 5d | 6d | 0d |  |  | Non-SIT S&A QT Test Team | Non-SIT S&A QT Test Team | S&A Qualification | 347.33 | 6.1 | Laura Kennedy | Green | GREEN |  |  |
| 1999 | 1.6.4.3.3.2 | Qualification Wave 2 Participant Test Readiness Confirmed | milestone | 0d | 2025-10-17 | 2025-10-17 | 1998, 1986, 1925, 1926 | 2025-10-17 | 2025-10-17 | 0d | 6d | 0d |  |  | Non-SIT S&A QT Test Team | Non-SIT S&A QT Test Team | S&A Qualification | 351.71 | 6.1 | Laura Kennedy | Green | GREEN | T3-QU-0033 | QAG |
| 2000 | 1.6.4.3.3.3 | Qualification Wave 2 Execution Start | milestone | 0d | 2025-10-20 | 2025-10-20 | 1999FS+1d, 1996 | 2025-10-20 | 2025-10-20 | 0d | 6d | 0d |  |  | Participants | Participants | S&A Qualification | 354.71 | 6.1 | Laura Kennedy | Green | GREEN | T3-QU-0034 | QAG |
| 2001 | 1.6.4.3.3.4 | Qualification Wave 2 QT Execution Window |  | 95d | 2025-10-20 | 2026-02-27 | 2000SS-1d | 2025-10-20 | 2026-02-27 | 94d | 11d | 0d |  |  | Participants | Participants | S&A Qualification | 354.33 | 6.1 | Laura Kennedy | Green | GREEN |  |  |
| 2002 | 1.6.4.3.3.5 | Qualfication Wave 2 QT Execution End | milestone | 0d | 2026-02-27 | 2026-02-27 | 2001 | 2026-02-27 | 2026-02-27 | 0d | 11d | 5d |  |  | Participants | Participants | S&A Qualification | 484.71 | 6.1 | Laura Kennedy | Green | GREEN | T3-QU-0055 | QAG |
| 2003 | 1.6.4.3.4 | **Qualification Wave 2 Exit** |  | 158d | 2025-10-20 | 2026-05-27 |  | 2025-10-20 | 2026-05-27 | 153d | 6d |  |  | -0 | N/A | N/A | S&A Qualification | -154.67 | 6.1 | N/A |  |  |  |  |
| 2004 | 1.6.4.3.4.1 | Final QAD Submission window opens | milestone | 0d | 2025-10-20 | 2025-10-20 | 2000 | 2025-10-20 | 2025-10-20 | 0d | 6d | 0d |  |  | Participants | Participants | S&A Qualification | 354.71 | 6.1 | Laura Kennedy | Green | GREEN |  |  |
| 2005 | 1.6.4.3.4.2 | Qualification Wave 2 Participants submit their Final QAD |  | 100d | 2025-10-20 | 2026-03-06 | 2004FS-1d | 2025-10-20 | 2026-03-06 | 99d | 6d | 0d |  |  | Participants | Participants | S&A Qualification | 354.33 | 6.1 | Laura Kennedy | Green | GREEN |  |  |
| 2006 | 1.6.4.3.4.3 | Qualification Wave 2 Participants have submitted their final QAD | milestone | 0d | 2026-03-06 | 2026-03-06 | 2005, 2002 | 2026-03-06 | 2026-03-06 | 0d | 6d | 0d |  |  | Participants | Participants | S&A Qualification | 491.71 | 6.1 | Laura Kennedy | Green | GREEN | T3-QU-0101 | QAG |
| 2007 | 1.6.4.3.4.4 | Completion of Code Bodies review of Final QAD |  | 26d | 2026-03-09 | 2026-04-13 | 2006 | 2026-03-09 | 2026-04-13 | 27d | 6d | 0d |  |  | Code Bodies | Code Bodies | S&A Qualification | 494.33 | 6.1 | Laura Kennedy | Green | GREEN |  |  |
| 2008 | 1.6.4.3.4.5 | QAD Sign Off deadline |  | 1d | 2026-04-20 | 2026-04-20 | 2007FS+4d | 2026-04-20 | 2026-04-20 | 1d | 6d | 0d |  |  | Participants | Participants | S&A Qualification | 536.33 | 6.1 | Laura Kennedy | Green | GREEN |  |  |
| 2009 | 1.6.4.3.4.6 | Qualification Wave 2 Participants Qualification approved by BSC PAB and REC Manager | milestone | 0d | 2026-05-27 | 2026-05-27 | 2008FS+27d | 2026-05-27 | 2026-05-27 | 0d | 6d | 0d |  |  | Code Bodies | Code Bodies | S&A Qualification | 573.71 | 6.1 | Laura Kennedy | Green | GREEN | T2-QU-0200 | QAG |
| 2010 | 1.6.4.4 | **Qualification Wave 3** |  | 249d | 2025-08-11 | 2026-07-23 |  | 2025-08-04 | 2026-07-23 | 239d | 0d |  |  | -0 | N/A | N/A | S&A Qualification | -133.67 | 6.1 | N/A |  |  |  |  |
| 2011 | 1.6.4.4.1 | **Qualification Wave 3 QAD Prep** |  | 95d | 2025-08-11 | 2025-12-19 |  | 2025-08-11 | 2025-12-19 | 95d | 0d |  |  | -0 | N/A | N/A | S&A Qualification | -154.67 | 6.1 | N/A |  |  |  |  |
| 2012 | 1.6.4.4.1.1 | Initial QAD Submission window opens | milestone | 0d | 2025-08-11 | 2025-08-11 | 1770FS+151d | 2025-08-11 | 2025-08-11 | 0d | 0d |  |  |  | Participants | Participants | S&A Qualification | 284.71 | 6.1 | Laura Kennedy | Green | GREEN |  |  |
| 2013 | 1.6.4.4.1.2 | Qualification Wave 3 Participants Submit Initial QAD |  | 65d | 2025-08-11 | 2025-11-07 | 2012FS-1d | 2025-08-11 | 2025-11-07 | 65d | 0d |  |  |  | Participants | Participants | S&A Qualification | 284.33 | 6.1 | Laura Kennedy | Green | GREEN |  |  |
| 2014 | 1.6.4.4.1.3 | Qualification Wave 3 Participants have submitted their initial QAD | milestone | 0d | 2025-11-07 | 2025-11-07 | 2013 | 2025-11-07 | 2025-11-07 | 0d | 0d |  |  |  | Participants | Participants | S&A Qualification | 372.71 | 6.1 | Laura Kennedy | Green | GREEN | T3-QU-0102 | QAG |
| 2015 | 1.6.4.4.1.4 | Code Bodies review of Wave 3 Participants' Initial QAD |  | 30d | 2025-11-10 | 2025-12-19 | 2014 | 2025-11-10 | 2025-12-19 | 30d | 0d |  |  |  | Code Bodies | Code Bodies | S&A Qualification | 375.33 | 6.1 | Laura Kennedy | Green | GREEN |  |  |
| 2016 | 1.6.4.4.1.5 | Completion of Code Bodies review of Initial QAD | milestone | 0d | 2025-12-19 | 2025-12-19 | 2015 | 2025-12-19 | 2025-12-19 | 0d | 0d |  |  |  | Code Bodies | Code Bodies | S&A Qualification | 414.71 | 6.1 | Laura Kennedy | Green | GREEN |  |  |
| 2017 | 1.6.4.4.2 | **Qualification Wave 3 Test Prep** |  | 65d | 2025-09-15 | 2025-12-12 |  | 2025-08-04 | 2025-10-31 | 65d | 25d |  |  | -0 | N/A | N/A | S&A Qualification | -555.67 | 6.1 | N/A |  |  |  |  |
| 2018 | 1.6.4.4.2.1 | Confirmation from Qualification Wave 3 Participants that DIP Onboarding has commenced | milestone | 0d | 2025-09-15 | 2025-09-15 |  | 2025-09-15 | 2025-09-15 | 0d | 30d | 0d | start no earlier than 2025-09-15 |  | Participants | Participants | S&A Qualification | 319.33 | 6.1 | Laura Kennedy | Green | GREEN | T3-QU-0025 | QAG |
| 2019 | 1.6.4.4.2.2 | Qualification Wave 3 Participants DIP Onboarding window |  | 35d | 2025-09-15 | 2025-10-31 | 2018 | 2025-09-15 | 2025-10-31 | 40d | 30d | 0d | start no earlier than 2025-08-04 |  | Participants | Participants | S&A Qualification | 319.33 | 6.1 | Laura Kennedy | Green | GREEN |  |  |
| 2020 | 1.6.4.4.2.3 | Confirmation from Qualification Wave 3 Participants that DIP onboarding has completed | milestone | 0d | 2025-10-31 | 2025-10-31 | 2019 | 2025-10-31 | 2025-10-31 | 0d | 30d |  | start no earlier than 2025-09-22 |  | Participants | Participants | S&A Qualification | 365.71 | 6.1 | Laura Kennedy | Green | GREEN |  |  |
| 2021 | 1.6.4.4.2.4 | Qualification Wave 3 Participants' to provide status of PIT completion and submit QT Test Plan | milestone | 0d | 2025-10-20 | 2025-10-20 |  | 2025-10-20 | 2025-10-20 | 0d | 0d |  | start no earlier than 2025-10-20 |  | Participants | Participants | S&A Qualification | 354.33 | 6.1 | Laura Kennedy | Green | GREEN | T3-QU-0103 | QAG |
| 2022 | 1.6.4.4.2.5 | Review of Participants' PIT Status and QT Test Plan |  | 15d | 2025-10-20 | 2025-11-07 | 2021 | 2025-10-20 | 2025-11-07 | 15d | 554d | 0d | start no earlier than 2025-09-08 |  | Code Bodies, Non-SIT S&A QT Test Team | Code Bodies, Non-SIT S&A QT Test Team | S&A Qualification | 354.33 | 6.1 | Laura Kennedy | Green | GREEN |  |  |
| 2023 | 1.6.4.4.2.6 | Qualification Test Plans for Wave 3 Participants approved | milestone | 0d | 2025-11-07 | 2025-11-07 | 2022 | 2025-11-07 | 2025-11-07 | 0d | 554d |  | start no earlier than 2025-09-26 |  | Non-SIT S&A QT Test Team | Non-SIT S&A QT Test Team | S&A Qualification | 372.71 | 6.1 | Laura Kennedy | Green | GREEN | T3-QU-0024 | QAG |
| 2024 | 1.6.4.4.2.7 | Qualification Wave 3 Participants have submitted PIT Test Completion Report and evidence for QT Entry | milestone | 0d | 2025-11-10 | 2025-11-10 |  | 2025-11-10 | 2025-11-10 | 0d | 0d |  | start no earlier than 2025-11-10 |  | Participants | Participants | S&A Qualification | 375.33 | 6.1 | Laura Kennedy | Green | GREEN | T3-QU-0104 | QAG |
| 2025 | 1.6.4.4.2.8 | Review of Participants' PIT Test Completion Report |  | 25d | 2025-11-10 | 2025-12-12 | 2024 | 2025-11-10 | 2025-12-12 | 30d | 0d |  | start no earlier than 2025-09-29 |  | Code Bodies, Non-SIT S&A QT Test Team | Code Bodies, Non-SIT S&A QT Test Team | S&A Qualification | 375.33 | 6.1 | Laura Kennedy | Green | GREEN |  |  |
| 2026 | 1.6.4.4.2.9 | Onboarding to QTF & ADO |  | 25d | 2025-11-10 | 2025-12-12 | 2025SS | 2025-11-10 | 2025-12-12 | 30d | 0d |  | finish no earlier than 2025-10-31 |  |  |  | S&A Qualification | 375.33 | 6.1 | Laura Kennedy | Green | GREEN |  |  |

Notes:
- 2000: 6/8/24: Date at risk from scenario planning activity
- 2009: 14/5: Baseline and name updated after cr48 approval at psg on 1/5

| ID | WBS | Task | Type | Duration | Start | Finish | Predecessors | Baseline start | Baseline finish | Baseline duration | Total slack | Free slack | Constraint | Baseline cost | Responsible | Involved | Text9 | Task Status | Update Version | MHHS Resource Name | Sched Status | RAG | Milestone ID | Text29 |
| --- | --- | --- | --- | --- | --- | --- | --- | --- | --- | --- | --- | --- | --- | --- | --- | --- | --- | --- | --- | --- | --- | --- | --- | --- |
| 2027 | 1.6.4.4.3 | **Qualification Wave 3 QT Execution** |  | 102d | 2025-11-03 | 2026-03-24 |  | 2025-11-03 | 2026-03-24 | 100d |  |  |  | -0 | N/A | N/A | S&A Qualification | -154.67 | 6.1 | N/A |  |  |  |  |
| 2028 | 1.6.4.4.3.1 | Review Entry Criteria Evidence for each Wave 3 Participant |  | 5d | 2025-12-15 | 2025-12-19 | 2020, 2016FF, 2026 | 2025-12-15 | 2025-12-19 | 5d | 0d |  | start no earlier than 2025-11-03 |  | Non-SIT S&A QT Test Team | Non-SIT S&A QT Test Team | S&A Qualification | 410.33 | 6.1 | Laura Kennedy | Green | GREEN |  |  |
| 2029 | 1.6.4.4.3.2 | Qualification Wave 3 Participant Test Readiness confirmed | milestone | 0d | 2025-12-19 | 2025-12-19 | 2020, 2028, 1930, 1931 | 2025-12-19 | 2025-12-19 | 0d | 0d |  |  |  | Non-SIT S&A QT Test Team | Non-SIT S&A QT Test Team | S&A Qualification | 414.71 | 6.1 | Laura Kennedy | Green | GREEN | T3-QU-0038 | QAG |
| 2030 | 1.6.4.4.3.3 | Qualification Wave 3 Execution Start | milestone | 0d | 2026-01-05 | 2026-01-05 | 2029FS+11d, 2026FS+1d | 2026-01-05 | 2026-01-05 | 0d | 0d |  | start no earlier than 2025-11-03 |  | Participants | Participants | S&A Qualification | 431.71 | 6.1 | Laura Kennedy | Green | GREEN | T3-QU-0039 | QAG |
| 2031 | 1.6.4.4.3.4 | Qualification Wave 3 QT Execution Window |  | 95d | 2026-01-05 | 2026-05-15 | 2028, 2030FS-1d | 2026-01-05 | 2026-05-15 | 95d | 5d | 0d |  |  | Participants | Participants | S&A Qualification | 431.33 | 6.1 | Laura Kennedy | Green | GREEN |  |  |
| 2032 | 1.6.4.4.3.5 | Qualification Wave 3 Projected Execution End | milestone | 0d | 2026-05-15 | 2026-05-15 | 2031 | 2026-05-15 | 2026-05-15 | 0d | 5d |  |  |  | Participants | Participants | S&A Qualification | 561.71 | 6.1 | Laura Kennedy | Green | GREEN | T3-QU-0056 | QAG |
| 2033 | 1.6.4.4.4 | **Qualification Wave 3 Exit** |  | 144d | 2026-01-05 | 2026-07-23 |  | 2026-01-05 | 2026-07-23 | 144d | 0d |  |  | -0 | N/A | N/A | S&A Qualification | -154.67 | 6.1 | N/A |  |  |  |  |
| 2034 | 1.6.4.4.4.1 | Final QAD Submission window opens | milestone | 0d | 2026-01-05 | 2026-01-05 | 2030 | 2026-01-05 | 2026-01-05 | 0d | 0d |  |  |  | Participants | Participants | S&A Qualification | 431.71 | 6.1 | Laura Kennedy | Green | GREEN |  |  |
| 2035 | 1.6.4.4.4.2 | Qualification Wave 3 Participants submit their Final QAD |  | 100d | 2026-01-05 | 2026-05-22 | 2034FS-1d | 2026-01-05 | 2026-05-22 | 100d | 0d |  |  |  | Participants | Participants | S&A Qualification | 431.33 | 6.1 | Laura Kennedy | Green | GREEN |  |  |
| 2036 | 1.6.4.4.4.3 | Qualification Wave 3 Participants have submitted their Final QAD | milestone | 0d | 2026-05-22 | 2026-05-22 | 2035, 2032 | 2026-05-22 | 2026-05-22 | 0d | 0d |  |  |  | Participants | Participants | S&A Qualification | 568.71 | 6.1 | Laura Kennedy | Green | GREEN | T3-QU-0105 | QAG |
| 2037 | 1.6.4.4.4.4 | Completion of Code Bodies review of Final QAD |  | 20d | 2026-05-25 | 2026-06-19 | 2036 | 2026-05-25 | 2026-06-19 | 20d | 0d |  |  |  | Code Bodies | Code Bodies | S&A Qualification | 571.33 | 6.1 | Laura Kennedy | Green | GREEN |  |  |
| 2038 | 1.6.4.4.4.5 | QAD Sign Off deadline |  | 1d | 2026-06-26 | 2026-06-26 | 2037FS+4d | 2026-06-26 | 2026-06-26 | 1d | 0d |  |  |  | Participants | Participants | S&A Qualification | 603.33 | 6.1 | Laura Kennedy | Green | GREEN |  |  |
| 2039 | 1.6.4.4.4.6 | Qualification Wave 3 Participants Qualification approved by BSC PAB and REC Manager | milestone | 0d | 2026-07-23 | 2026-07-23 | 2038FS+19d | 2026-07-23 | 2026-07-23 | 0d | 0d |  |  |  | Code Bodies | Code Bodies | S&A Qualification | 630.71 | 6.1 | Laura Kennedy | Green | GREEN | T2-QU-0250 | QAG |
| 2040 | 1.6.4.5 | **Qualification Wave 4** |  | 334d | 2025-10-20 | 2027-01-28 |  | 2025-09-22 | 2027-01-28 | 249d | 4d |  |  | -0 | N/A | N/A | S&A Qualification | -133.67 | 6.1 | N/A |  |  |  |  |
| 2041 | 1.6.4.5.1 | **Qualification Wave 4 QAD Prep** |  | 95d | 2025-10-20 | 2026-02-27 |  | 2025-10-20 | 2026-02-27 | 99d | 4d |  |  | -0 | N/A | N/A | S&A Qualification | -155.67 | 6.1 | N/A |  |  |  |  |
| 2042 | 1.6.4.5.1.1 | Initial QAD Submission window opens | milestone | 0d | 2025-10-20 | 2025-10-20 | 1771FS+161d | 2025-10-20 | 2025-10-20 | 0d | 4d | 0d |  |  | Participants | Participants | S&A Qualification | 354.71 | 6.1 | Laura Kennedy | Green | GREEN |  |  |
| 2043 | 1.6.4.5.1.2 | Qualification Wave 4 Participants Submit Initial QAD |  | 65d | 2025-10-20 | 2026-01-16 | 2042FS-1d | 2025-10-20 | 2026-01-16 | 70d | 4d | 0d |  |  | Participants | Participants | S&A Qualification | 354.33 | 6.1 | Laura Kennedy | Green | GREEN |  |  |
| 2044 | 1.6.4.5.1.3 | Qualification Wave 4 Participants have submitted their Initial QAD | milestone | 0d | 2026-01-16 | 2026-01-16 | 2043 | 2026-01-16 | 2026-01-16 | 0d | 4d | 0d |  |  | Participants | Participants | S&A Qualification | 442.71 | 6.1 | Laura Kennedy | Green | GREEN | T3-QU-0106 | QAG |
| 2045 | 1.6.4.5.1.4 | Code Bodies review of Wave 4 Participants' Initial QAD |  | 30d | 2026-01-19 | 2026-02-27 | 2044 | 2026-01-19 | 2026-02-27 | 29d | 4d | 0d |  |  | Code Bodies | Code Bodies | S&A Qualification | 445.33 | 6.1 | Laura Kennedy | Green | GREEN |  |  |
| 2046 | 1.6.4.5.1.5 | Completion of Code Bodies review of Initial QAD | milestone | 0d | 2026-02-27 | 2026-02-27 | 2045 | 2026-02-27 | 2026-02-27 | 0d | 4d | 0d |  |  | Code Bodies | Code Bodies | S&A Qualification | 484.71 | 6.1 | Laura Kennedy | Green | GREEN |  |  |
| 2047 | 1.6.4.5.2 | **Qualification Wave 4 Test Prep** |  | 65d | 2025-11-03 | 2026-01-30 |  | 2025-09-22 | 2025-12-19 | 67d | 30d |  |  | -0 | N/A | N/A | S&A Qualification | -555.67 | 6.1 | N/A |  |  |  |  |
| 2048 | 1.6.4.5.2.1 | Confirmation from Qualification 4 Participants that DIP Onboarding has commenced | milestone | 0d | 2025-11-03 | 2025-11-03 |  | 2025-11-03 | 2025-11-03 | 0d | 49d | 0d | start no earlier than 2025-11-03 |  | Participants | Participants | S&A Qualification | 368.33 | 6.1 | Laura Kennedy | Green | GREEN | T3-QU-0031 | QAG |
| 2049 | 1.6.4.5.2.2 | Qualification Wave 4 Participants DIP Onboarding Window |  | 35d | 2025-11-03 | 2025-12-19 | 2048 | 2025-11-03 | 2025-12-19 | 42d | 49d | 0d |  |  | Participants | Participants | S&A Qualification | 368.33 | 6.1 | Laura Kennedy | Green | GREEN |  |  |
| 2050 | 1.6.4.5.2.3 | Confirmation from Qualification Wave 4 Participants that DIP onboarding has completed | milestone | 0d | 2025-12-19 | 2025-12-19 | 2049 | 2025-12-19 | 2025-12-19 | 0d | 49d | 45d |  |  | Participants | Participants | S&A Qualification | 414.71 | 6.1 | Laura Kennedy | Green | GREEN |  |  |
| 2051 | 1.6.4.5.2.4 | Qualification Wave 4 Participants' to provide status of PIT completion and submit QT Test Plan | milestone | 0d | 2025-12-08 | 2025-12-08 |  | 2025-12-08 | 2025-12-08 | 0d | 19d | 0d | start no earlier than 2025-12-08 |  | Participants | Participants | S&A Qualification | 403.33 | 6.1 | Laura Kennedy | Green | GREEN | T3-QU-0107 | QAG |
| 2052 | 1.6.4.5.2.5 | Review of Participants' PIT Status and QT Test Plan |  | 15d | 2025-12-08 | 2025-12-26 | 2051 | 2025-12-08 | 2025-12-26 | 16d | 30d | 0d |  |  | Code Bodies, Non-SIT S&A QT Test Team | Code Bodies, Non-SIT S&A QT Test Team | S&A Qualification | 403.33 | 6.1 | Laura Kennedy | Green | GREEN |  |  |
| 2053 | 1.6.4.5.2.6 | Qualification Test Plans for Qualification Wave 4 Participants approved | milestone | 0d | 2025-12-26 | 2025-12-26 | 2052 | 2025-12-26 | 2025-12-26 | 0d | 30d | 0d |  |  | Non-SIT S&A QT Test Team | Non-SIT S&A QT Test Team | S&A Qualification | 421.71 | 6.1 | Laura Kennedy | Green | GREEN | T3-QU-0030 | QAG |
| 2054 | 1.6.4.5.2.7 | Qualification Wave 4 Participants have submitted PIT Test Completion Report and evidence for QT entry | milestone | 0d | 2025-12-26 | 2025-12-26 | 2053 | 2025-12-26 | 2025-12-26 | 0d | 30d | 0d |  |  | Participants | Participants | S&A Qualification | 421.71 | 6.1 | Laura Kennedy | Green | GREEN | T3-QU-0108 | QAG |
| 2055 | 1.6.4.5.2.8 | Review of Participants' PIT Test Completion Report |  | 25d | 2025-12-29 | 2026-01-30 | 2054 | 2025-12-29 | 2026-01-30 | 30d | 30d | 0d |  |  | Code Bodies, Non-SIT S&A QT Test Team | Code Bodies, Non-SIT S&A QT Test Team | S&A Qualification | 424.33 | 6.1 | Laura Kennedy | Green | GREEN |  |  |
| 2056 | 1.6.4.5.2.9 | Onboarding to QTF & ADO |  | 20d | 2025-12-29 | 2026-01-23 | 2055SS | 2025-12-29 | 2026-01-23 | 30d | 30d | 26d | start no earlier than 2025-11-24 |  | Code Bodies, Non-SIT S&A QT Test Team | Code Bodies, Non-SIT S&A QT Test Team | S&A Qualification | 424.33 | 6.1 | Laura Kennedy | Green | GREEN |  |  |

Notes:
- 2030: 6/8/24: Date at risk from scenario planning activity
- 2039: 14/5: Baseline and name updated after cr48 approval at psg on 1/5

| ID | WBS | Task | Type | Duration | Start | Finish | Predecessors | Complete | Remaining | Baseline start | Baseline finish | Baseline duration | Baseline 1 start | Baseline 1 finish | Total slack | Free slack | Constraint | Baseline cost | Responsible | Involved | Text9 | Task Status | Update Version | MHHS Resource Name | Sched Status | RAG | Milestone ID | Text29 | MHHS Programme Phase | Tier | Artefact ID |
| --- | --- | --- | --- | --- | --- | --- | --- | --- | --- | --- | --- | --- | --- | --- | --- | --- | --- | --- | --- | --- | --- | --- | --- | --- | --- | --- | --- | --- | --- | --- | --- |
| 2057 | 1.6.4.5.3 | **Qualification Wave 4 QT Execution** |  | 100d | 2026-02-23 | 2026-07-10 |  |  |  | 2026-02-23 | 2026-07-10 | 101d |  |  | 4d |  |  | -0 | N/A | N/A | S&A Qualification | -155.67 | 6.1 | N/A |  |  |  |  |  |  |  |
| 2058 | 1.6.4.5.3.1 | Review Entry Criteria Evidence for each Wave 4 Participant |  | 5d | 2026-02-23 | 2026-02-27 | 2046FF, 2050 |  |  | 2026-02-23 | 2026-02-27 | 5d |  |  | 4d | 0d | start no earlier than 2026-01-05 |  | Non-SIT S&A QT Test Team | Non-SIT S&A QT Test Team | S&A Qualification | 480.33 | 6.1 | Laura Kennedy | Green | GREEN |  |  |  |  |  |
| 2059 | 1.6.4.5.3.2 | Qualification Wave 4 Participant Test Readiness Confirmed | milestone | 0d | 2026-02-27 | 2026-02-27 | 2050, 2058, 1935, 1936 |  |  | 2026-02-27 | 2026-02-27 | 0d |  |  | 4d | 0d |  |  | Non-SIT S&A QT Test Team | Non-SIT S&A QT Test Team | S&A Qualification | 484.71 | 6.1 | Laura Kennedy | Green | GREEN | T3-QU-0043 | QAG |  |  |  |
| 2060 | 1.6.4.5.3.3 | Qualification Wave 4 QT Execution Start | milestone | 0d | 2026-03-02 | 2026-03-02 | 2059FS+1d, 2056 |  |  | 2026-03-02 | 2026-03-02 | 0d |  |  | 4d | 0d | start no earlier than 2026-01-07 |  | Participants | Participants | S&A Qualification | 487.71 | 6.1 | Laura Kennedy | Green | GREEN | T3-QU-0044 | QAG |  |  |  |
| 2061 | 1.6.4.5.3.4 | Qualification Wave 4 QT Execution Window |  | 95d | 2026-03-02 | 2026-07-10 | 2060FS-1d, 2058 |  |  | 2026-03-02 | 2026-07-10 | 96d |  |  | 9d | 0d |  |  | Participants | Participants | S&A Qualification | 487.33 | 6.1 | Laura Kennedy | Green | GREEN |  |  |  |  |  |
| 2062 | 1.6.4.5.3.5 | Qualification Wave 4 Projected Execution End | milestone | 0d | 2026-07-10 | 2026-07-10 | 2061 |  |  | 2026-07-10 | 2026-07-10 | 0d |  |  | 9d | 5d |  |  | Participants | Participants | S&A Qualification | 617.71 | 6.1 | Laura Kennedy | Green | GREEN | T3-QU-0057 | QAG |  |  |  |
| 2063 | 1.6.4.5.4 | **Qualification Wave 4 Exit** |  | 145d | 2026-03-02 | 2026-09-18 |  |  |  | 2026-03-02 | 2026-09-18 | 150d |  |  | 4d |  |  | -0 | N/A | N/A | S&A Qualification | -155.67 | 6.1 | N/A |  |  |  |  |  |  |  |
| 2064 | 1.6.4.5.4.1 | Final QAD Submission window opens | milestone | 0d | 2026-03-02 | 2026-03-02 | 2060 |  |  | 2026-03-02 | 2026-03-02 | 0d |  |  | 4d | 0d |  |  | Participants | Participants | S&A Qualification | 487.71 | 6.1 | Laura Kennedy | Green | GREEN |  |  |  |  |  |
| 2065 | 1.6.4.5.4.2 | Qualification Wave 4 Participants submit their Final QAD |  | 100d | 2026-03-02 | 2026-07-17 | 2064FS-1d |  |  | 2026-03-02 | 2026-07-17 | 101d |  |  | 4d | 0d |  |  | Participants | Participants | S&A Qualification | 487.33 | 6.1 | Laura Kennedy | Green | GREEN |  |  |  |  |  |
| 2066 | 1.6.4.5.4.3 | Qualification Wave 4 Participants have submitted their Final QAD | milestone | 0d | 2026-07-17 | 2026-07-17 | 2065, 2062 |  |  | 2026-07-17 | 2026-07-17 | 0d |  |  | 4d | 0d |  |  | Participants | Participants | S&A Qualification | 624.71 | 6.1 | Laura Kennedy | Green | GREEN | T3-QU-0109 | QAG |  |  |  |
| 2067 | 1.6.4.5.4.4 | Completion of Code Bodies review of Final QAD |  | 20d | 2026-07-20 | 2026-08-14 | 2066 |  |  | 2026-07-20 | 2026-08-14 | 25d |  |  | 4d | 0d |  |  | Code Bodies | Code Bodies | S&A Qualification | 627.33 | 6.1 | Laura Kennedy | Green | GREEN |  |  |  |  |  |
| 2068 | 1.6.4.5.4.5 | QAD Sign Off deadline |  | 1d | 2026-08-21 | 2026-08-21 | 2067FS+4d |  |  | 2026-08-21 | 2026-08-21 | 1d |  |  | 4d | 0d |  |  | Participants | Participants | S&A Qualification | 659.33 | 6.1 | Laura Kennedy | Green | GREEN |  |  |  |  |  |
| 2069 | 1.6.4.5.4.6 | Qualification Wave 4 Participants Qualification approved by BSC PAB and REC Manager | milestone | 0d | 2026-09-18 | 2026-09-18 | 2068FS+20d |  |  | 2026-09-18 | 2026-09-18 | 0d |  |  | 4d | 0d |  |  | Code Bodies | Code Bodies | S&A Qualification | 687.71 | 6.1 | Laura Kennedy | Green | GREEN | T2-QU-0300 | QAG |  |  |  |
| 2070 | 1.6.4.5.5 | **Qualification Tier 1 Milestone** |  | 66d | 2026-10-28 | 2027-01-28 |  |  |  | 2026-10-28 | 2027-01-28 | 0d |  |  | 235d |  |  |  |  |  | S&A Qualification | -686.67 |  |  | Overdue Start |  |  |  |  |  |  |
| 2071 | 1.6.4.5.5.1 | All suppliers must be able to access MPANs under the new TOM (M14) | milestone | 0d | 2026-10-28 | 2026-10-28 | 2069FS+28d |  |  | 2026-10-28 | 2026-10-28 | 0d | 2026-03-16 | 2026-03-16 | 235d | 0d | start no earlier than 2026-03-12 |  | CPT | CPT | S&A Qualification | 727.71 | 6.1 | CPT | Green | GREEN | T1-MI-5000 | PSG | Migration | T1 |  |
| 2072 | 1.6.4.5.5.2 | All suppliers must be able to access MPANs under the new TOM (M14*) - Late Exit | milestone | 0d | 2027-01-28 | 2027-01-28 | 2071FS+66d |  |  | 2027-01-28 | 2027-01-28 | 0d | 2026-06-16 | 2026-06-16 | 235d |  |  |  | CPT | CPT | S&A Qualification | 819.71 | 6.1 | CPT | Green | GREEN | T1-MI-5500 | PSG | Migration | T1 |  |
| 2073 | 1.7 | **REGULATORY** |  | 823d | 2022-10-31 A | 2025-12-24 |  | 95% | 41.91d | 2022-10-31 | 2025-12-24 | 680d | 2022-10-31 | 2025-03-07 | 521d |  |  | -0 | N/A | N/A | Regulatory |  |  | N/A |  |  |  |  | Regulatory |  |  |
| 2074 | 1.7.1 | **Baseline MHHS Code Changes** |  | 475d | 2022-10-31 A | 2024-08-23 A |  | 100% |  | 2022-10-31 | 2024-08-23 | 475d | 2022-10-31 | 2024-08-23 |  |  |  | -0 | N/A | N/A | Regulatory |  | 5.0 | N/A |  |  |  |  | Regulatory |  |  |
| 2075 | 1.7.1.1 | **Preparation and planning** |  | 35d | 2022-10-31 A | 2022-12-16 A |  | 100% |  | 2022-10-31 | 2022-12-16 | 35d | 2022-10-31 | 2022-12-16 |  |  |  |  | N/A | N/A | Regulatory |  | 5.0 | N/A |  |  |  |  | Regulatory |  |  |
| 2076 | 1.7.1.1.1 | Impact assessment of Programme design on codes to determine required changes |  | 20d | 2022-10-31 A | 2022-11-25 A | 47 | 100% |  | 2022-10-31 | 2022-11-25 | 20d | 2022-10-31 | 2022-11-25 |  |  |  |  | Code Bodies,SRO Code Drafters | Code Drafting PM | Regulatory |  | 5.0 | Andrew Margan | Complete | COMPLETE |  |  | Regulatory |  |  |
| 2077 | 1.7.1.1.2 | Become 'code draft ready' |  | 35d | 2022-10-31 A | 2022-12-16 A |  | 100% |  | 2022-10-31 | 2022-12-16 | 35d | 2022-10-31 | 2022-12-16 |  |  |  |  | Code Bodies,SRO Code Drafters | Code Drafting PM | Regulatory |  | 5.0 | Andrew Margan | Complete | COMPLETE |  |  | Regulatory |  |  |
| 2078 | 1.7.1.1.3 | Soft start drafting where possible |  | 35d | 2022-10-31 A | 2022-12-16 A |  | 100% |  | 2022-10-31 | 2022-12-16 | 35d | 2022-10-31 | 2022-12-16 |  |  |  |  | Code Bodies,SRO Code Drafters | Code Drafting PM | Regulatory |  | 5.0 | Andrew Margan | Complete | COMPLETE |  |  | Regulatory |  |  |
| 2079 | 1.7.1.2 | **Code drafting** |  | 443d | 2022-12-12 A | 2024-08-21 A |  | 100% |  | 2022-12-12 | 2024-08-21 | 445d | 2022-12-12 | 2024-08-23 |  |  |  | -0 | N/A | N/A | Regulatory | M6 | 5.0 | N/A |  |  |  |  | Regulatory |  |  |
| 2080 | 1.7.1.2.1 | **Data Services (BSC driven)** |  | 118d | 2022-12-12 A | 2023-05-24 A |  | 100% |  | 2022-12-12 | 2023-05-24 | 118d | 2022-12-12 | 2023-05-24 |  |  |  |  | N/A | N/A | Regulatory | M6 | 5.0 | N/A |  |  |  |  | Regulatory |  |  |
| 2081 | 1.7.1.2.1.1 | Pre Code Drafting activities |  | 5d | 2022-12-12 A | 2022-12-16 A |  | 100% |  | 2022-12-12 | 2022-12-16 | 5d | 2022-12-12 | 2022-12-16 |  |  | start no earlier than 2022-12-12 |  | Code Drafting PM |  | Regulatory |  | 5.0 | Andrew Margan | Complete | COMPLETE |  |  | Regulatory |  |  |
| 2082 | 1.7.1.2.1.2 | Code and subsidiary document drafting takes place offline |  | 19d | 2023-01-03 A | 2023-01-27 A | 2081FS+11d | 100% |  | 2023-01-03 | 2023-01-27 | 19d | 2023-01-03 | 2023-01-27 |  |  |  |  | Code Bodies,SRO Design | Code Drafting PM | Regulatory |  | 5.0 | Andrew Margan | Complete | COMPLETE |  |  | Regulatory |  |  |
| 2083 | 1.7.1.2.1.3 | Internal review and cross-checking of drafting across code drafters |  | 11d | 2023-01-30 A | 2023-02-13 A | 2082 | 100% |  | 2023-01-30 | 2023-02-13 | 11d | 2023-01-30 | 2023-02-13 |  |  |  |  | Code Bodies,SRO Design | Code Drafting PM | Regulatory |  | 5.0 | Andrew Margan | Complete | COMPLETE |  |  | Regulatory |  |  |
| 2084 | 1.7.1.2.1.4 | External industry review via consultation |  | 20d | 2023-02-14 A | 2023-03-13 A | 2083 | 100% |  | 2023-02-14 | 2023-03-13 | 20d | 2023-02-14 | 2023-03-13 |  |  |  |  | PP | Code Drafting PM | Regulatory |  | 5.0 | Andrew Margan | Complete | COMPLETE |  |  | Regulatory |  |  |
| 2085 | 1.7.1.2.1.5 | Triage and action comments |  | 19d | 2023-03-10 A | 2023-04-05 A | 2084FS-2d | 100% |  | 2023-03-10 | 2023-04-05 | 19d | 2023-03-10 | 2023-04-05 |  |  |  |  | Code Bodies,SRO Design | Code Drafting PM | Regulatory |  | 5.0 | Andrew Margan | Complete | COMPLETE |  |  | Regulatory |  |  |
| 2086 | 1.7.1.2.1.6 | CDWG review |  | 30d | 2023-04-06 A | 2023-05-17 A | 2085 | 100% |  | 2023-04-06 | 2023-05-17 | 30d | 2023-04-06 | 2023-05-17 |  |  |  |  | PP | Code Drafting PM | Regulatory |  | 5.0 | Andrew Margan | Complete | COMPLETE |  |  | Regulatory |  |  |
| 2087 | 1.7.1.2.1.7 | CCAG review |  | 5d | 2023-05-18 A | 2023-05-24 A | 2086 | 100% |  | 2023-05-18 | 2023-05-24 | 5d | 2023-05-18 | 2023-05-24 |  |  |  |  | PP |  | Regulatory |  | 5.0 | Andrew Margan | Complete | COMPLETE |  |  | Regulatory |  |  |
| 2088 | 1.7.1.2.1.8 | Code drafting for Data Services topic area approved | milestone | 0d | 2023-05-24 A | 2023-05-24 A | 2087 | 100% |  | 2023-05-24 | 2023-05-24 | 0d | 2023-05-24 | 2023-05-24 |  |  |  |  | PP | Code Drafting PM | Regulatory |  | 5.0 | Andrew Margan | Complete | COMPLETE | T2-RE-0100 | CCAG | Regulatory | T2 | MHHS-ART060 |

Notes:
- 2060: 6/8/24: Date at risk from scenario planning activity
- 2069: 14/5: Baseline and name updated after cr48 approval at psg on 1/5
- 2071: Text3: All suppliers must be able to accept MPANs under the new TOM (one way gate)
- 2072: Text3: All suppliers must be able to accept MPANs under the new TOM (one way gate)

| ID | WBS | Task | Type | Duration | Start | Finish | Predecessors | Complete | Baseline start | Baseline finish | Baseline duration | Baseline 1 start | Baseline 1 finish | Constraint | Responsible | Involved | Text9 | Task Status | Update Version | MHHS Resource Name | MHHS Programme Phase | Sched Status | RAG | Artefact ID | Milestone ID | Text29 | Tier |
| --- | --- | --- | --- | --- | --- | --- | --- | --- | --- | --- | --- | --- | --- | --- | --- | --- | --- | --- | --- | --- | --- | --- | --- | --- | --- | --- | --- |
| 2089 | 1.7.1.2.2 | **Metering (REC driven)** |  | 118d | 2022-12-12 A | 2023-05-24 A |  | 100% | 2022-12-12 | 2023-05-24 | 118d | 2022-12-12 | 2023-05-24 |  | N/A | N/A | Regulatory | M6 | 5.0 | N/A | Regulatory |  |  |  |  |  |  |
| 2090 | 1.7.1.2.2.1 | Pre Code Drafting activities |  | 5d | 2022-12-12 A | 2022-12-16 A | 2081SS | 100% | 2022-12-12 | 2022-12-16 | 5d | 2022-12-12 | 2022-12-16 |  | Code Drafting PM |  | Regulatory |  | 5.0 | Andrew Margan | Regulatory | Complete | COMPLETE |  |  |  |  |
| 2091 | 1.7.1.2.2.2 | Code and subsidiary document drafting takes place offline |  | 19d | 2023-01-03 A | 2023-01-27 A | 2090FS+11d | 100% | 2023-01-03 | 2023-01-27 | 19d | 2023-01-03 | 2023-01-27 |  | Code Bodies,SRO Design | Code Drafting PM | Regulatory |  | 5.0 | Andrew Margan | Regulatory | Complete | COMPLETE |  |  |  |  |
| 2092 | 1.7.1.2.2.3 | Internal review and cross-checking of drafting across code drafters |  | 11d | 2023-01-30 A | 2023-02-13 A | 2091 | 100% | 2023-01-30 | 2023-02-13 | 11d | 2023-01-30 | 2023-02-13 |  | Code Bodies,SRO Design | Code Drafting PM | Regulatory |  | 5.0 | Andrew Margan | Regulatory | Complete | COMPLETE |  |  |  |  |
| 2093 | 1.7.1.2.2.4 | External industry review via consultation |  | 20d | 2023-02-14 A | 2023-03-13 A | 2092 | 100% | 2023-02-14 | 2023-03-13 | 20d | 2023-02-14 | 2023-03-13 |  | PP | Code Drafting PM | Regulatory |  | 5.0 | Andrew Margan | Regulatory | Complete | COMPLETE |  |  |  |  |
| 2094 | 1.7.1.2.2.5 | Triage and action comments |  | 19d | 2023-03-10 A | 2023-04-05 A | 2093FS-2d | 100% | 2023-03-10 | 2023-04-05 | 19d | 2023-03-10 | 2023-04-05 |  | Code Bodies,SRO Design | Code Drafting PM | Regulatory |  | 5.0 | Andrew Margan | Regulatory | Complete | COMPLETE |  |  |  |  |
| 2095 | 1.7.1.2.2.6 | CDWG review |  | 30d | 2023-04-06 A | 2023-05-17 A | 2094 | 100% | 2023-04-06 | 2023-05-17 | 30d | 2023-04-06 | 2023-05-17 |  | PP | Code Drafting PM | Regulatory |  | 5.0 | Andrew Margan | Regulatory | Complete | COMPLETE |  |  |  |  |
| 2096 | 1.7.1.2.2.7 | CCAG review |  | 5d | 2023-05-18 A | 2023-05-24 A | 2095 | 100% | 2023-05-18 | 2023-05-24 | 5d | 2023-05-18 | 2023-05-24 |  | PP |  | Regulatory |  | 5.0 | Andrew Margan | Regulatory | Complete | COMPLETE |  |  |  |  |
| 2097 | 1.7.1.2.2.8 | Code drafting for Metering topic area approved | milestone | 0d | 2023-05-24 A | 2023-05-24 A | 2096 | 100% | 2023-05-24 | 2023-05-24 | 0d | 2023-05-24 | 2023-05-24 |  | PP | Code Drafting PM | Regulatory |  | 5.0 | Andrew Margan | Regulatory | Complete | COMPLETE | MHHS-ART060 | T2-RE-0150 | CCAG | T2 |
| 2098 | 1.7.1.2.3 | **BSC Central Services (BSC driven)** |  | 156d | 2023-02-22 A | 2023-09-27 A |  | 100% | 2023-02-22 | 2023-09-27 | 156d | 2023-02-22 | 2023-09-14 |  | N/A | N/A | Regulatory | M6 | 5.0 | N/A | Regulatory |  |  |  |  |  |  |
| 2099 | 1.7.1.2.3.1 | Pre Code Drafting activities |  | 5d | 2023-02-22 A | 2023-02-28 A | 2100SS-5d | 100% | 2023-02-22 | 2023-02-28 | 5d | 2023-02-22 | 2023-02-28 |  | Code Drafting PM |  | Regulatory |  | 5.0 | Andrew Margan | Regulatory | Complete | COMPLETE |  |  |  |  |
| 2100 | 1.7.1.2.3.2 | Code Drafting (offline) |  | 80d | 2023-03-01 A | 2023-06-20 A | 2084SS | 100% | 2023-03-01 | 2023-06-20 | 80d | 2023-03-01 | 2023-06-20 | must start on 2023-03-01 | Code Bodies,SRO Design | Code Drafting PM | Regulatory |  | 5.0 | Andrew Margan | Regulatory | Complete | COMPLETE |  |  |  |  |
| 2101 | 1.7.1.2.3.3 | Internal review and cross-checking of drafting across code drafters |  | 70d | 2023-03-15 A | 2023-06-20 A | 2100SS+10d | 100% | 2023-03-15 | 2023-06-20 | 70d | 2023-03-15 | 2023-06-20 |  | Code Bodies,SRO Design | Code Drafting PM | Regulatory |  | 5.0 | Andrew Margan | Regulatory | Complete | COMPLETE |  |  |  |  |
| 2102 | 1.7.1.2.3.4 | External industry review via consultation |  | 15d | 2023-06-21 A | 2023-07-11 A | 2101 | 100% | 2023-06-21 | 2023-07-11 | 15d | 2023-06-21 | 2023-07-11 |  | PP | Code Drafting PM | Regulatory |  | 5.0 | Andrew Margan | Regulatory | Complete | COMPLETE |  |  |  |  |
| 2103 | 1.7.1.2.3.5 | Triage and action comments |  | 19d | 2023-07-10 A | 2023-08-03 A | 2102FS-2d | 100% | 2023-07-10 | 2023-08-03 | 19d | 2023-07-10 | 2023-08-03 |  | Code Bodies,SRO Design | Code Drafting PM | Regulatory |  | 5.0 | Andrew Margan | Regulatory | Complete | COMPLETE |  |  |  |  |
| 2104 | 1.7.1.2.3.6 | CDWG review |  | 28d | 2023-08-04 A | 2023-09-12 A | 2103 | 100% | 2023-08-04 | 2023-09-12 | 28d | 2023-08-04 | 2023-09-07 |  | PP | Code Drafting PM | Regulatory |  | 5.0 | Andrew Margan | Regulatory | Complete | COMPLETE |  |  |  |  |
| 2105 | 1.7.1.2.3.7 | CCAG review |  | 11d | 2023-09-13 A | 2023-09-27 A | 2104 | 100% | 2023-09-13 | 2023-09-27 | 11d | 2023-09-08 | 2023-09-14 |  | PP |  | Regulatory |  | 5.0 | Andrew Margan | Regulatory | Complete | COMPLETE |  |  |  |  |
| 2106 | 1.7.1.2.3.8 | Code drafting for BSC Central Services topic area approved | milestone | 0d | 2023-09-27 A | 2023-09-27 A | 2105 | 100% | 2023-09-27 | 2023-09-27 | 0d | 2023-09-14 | 2023-09-14 |  | PP | Code Drafting PM | Regulatory |  | 5.0 | Andrew Margan | Regulatory | Complete | COMPLETE | MHHS-ART060 | T2-RE-0200 | CCAG | T2 |
| 2107 | 1.7.1.2.4 | **Registration (BSC & REC driven)** |  | 131d | 2023-02-22 A | 2023-08-23 A |  | 100% | 2023-02-22 | 2023-08-23 | 131d | 2023-02-22 | 2023-08-23 |  | N/A | N/A | Regulatory | M6 | 5.0 | N/A | Regulatory |  |  |  |  |  |  |
| 2108 | 1.7.1.2.4.1 | Pre Code Drafting activities |  | 5d | 2023-02-22 A | 2023-02-28 A | 2109SS-5d | 100% | 2023-02-22 | 2023-02-28 | 5d | 2023-02-22 | 2023-02-28 |  | Code Drafting PM |  | Regulatory |  | 5.0 | Andrew Margan | Regulatory | Complete | COMPLETE |  |  |  |  |
| 2109 | 1.7.1.2.4.2 | Code Drafting (offline) |  | 65d | 2023-03-01 A | 2023-05-30 A | 2083, 2092 | 100% | 2023-03-01 | 2023-05-30 | 65d | 2023-03-01 | 2023-05-30 | must start on 2023-03-01 | Code Bodies,SRO Design | Code Drafting PM | Regulatory |  | 5.0 | Andrew Margan | Regulatory | Complete | COMPLETE |  |  |  |  |
| 2110 | 1.7.1.2.4.3 | Internal review and cross-checking of drafting across code drafters |  | 55d | 2023-03-15 A | 2023-05-30 A | 2109SS+10d | 100% | 2023-03-15 | 2023-05-30 | 55d | 2023-03-15 | 2023-05-30 |  | Code Bodies,SRO Design | Code Drafting PM | Regulatory |  | 5.0 | Andrew Margan | Regulatory | Complete | COMPLETE |  |  |  |  |
| 2111 | 1.7.1.2.4.4 | External industry review via consultation |  | 15d | 2023-05-31 A | 2023-06-20 A | 2110 | 100% | 2023-05-31 | 2023-06-20 | 15d | 2023-05-31 | 2023-06-20 |  | PP | Code Drafting PM | Regulatory |  | 5.0 | Andrew Margan | Regulatory | Complete | COMPLETE |  |  |  |  |
| 2112 | 1.7.1.2.4.5 | Triage and action comments |  | 19d | 2023-06-19 A | 2023-07-13 A | 2111FS-2d | 100% | 2023-06-19 | 2023-07-13 | 19d | 2023-06-19 | 2023-07-13 |  | Code Bodies,SRO Design | Code Drafting PM | Regulatory |  | 5.0 | Andrew Margan | Regulatory | Complete | COMPLETE |  |  |  |  |
| 2113 | 1.7.1.2.4.6 | CDWG review |  | 18d | 2023-07-14 A | 2023-08-08 A | 2112 | 100% | 2023-07-14 | 2023-08-08 | 18d | 2023-07-14 | 2023-08-16 |  | PP | Code Drafting PM | Regulatory |  | 5.0 | Andrew Margan | Regulatory | Complete | COMPLETE |  |  |  |  |
| 2114 | 1.7.1.2.4.7 | CCAG review |  | 11d | 2023-08-09 A | 2023-08-23 A | 2113 | 100% | 2023-08-09 | 2023-08-23 | 11d | 2023-08-17 | 2023-08-23 |  | PP |  | Regulatory |  | 5.0 | Andrew Margan | Regulatory | Complete | COMPLETE |  |  |  |  |
| 2115 | 1.7.1.2.4.8 | Code drafting for Registration topic area approved | milestone | 0d | 2023-08-23 A | 2023-08-23 A | 2114 | 100% | 2023-08-23 | 2023-08-23 | 0d | 2023-08-23 | 2023-08-23 |  | PP | Code Drafting PM | Regulatory |  | 5.0 | Andrew Margan | Regulatory | Complete | COMPLETE | MHHS-ART060 | T2-RE-0250 | CCAG | T2 |

| ID | WBS | Task | Type | Duration | Start | Finish | Predecessors | Complete | Baseline start | Baseline finish | Baseline duration | Baseline 1 start | Baseline 1 finish | Responsible | Involved | Text9 | Task Status | Update Version | MHHS Resource Name | MHHS Programme Phase | Sched Status | RAG | Artefact ID | Milestone ID | Text29 | Tier |
| --- | --- | --- | --- | --- | --- | --- | --- | --- | --- | --- | --- | --- | --- | --- | --- | --- | --- | --- | --- | --- | --- | --- | --- | --- | --- | --- |
| 2116 | 1.7.1.2.5 | **Governance and Qualification (BSC & REC driven)** |  | 130d | 2023-05-25 A | 2023-11-22 A |  | 100% | 2023-05-25 | 2023-11-22 | 130d | 2023-05-25 | 2023-11-13 | N/A | N/A | Regulatory | M6 | 5.0 | N/A | Regulatory |  |  |  |  |  |  |
| 2117 | 1.7.1.2.5.1 | Pre Code Drafting activities |  | 5d | 2023-05-25 A | 2023-05-31 A | 2118SS-5d | 100% | 2023-05-25 | 2023-05-31 | 5d | 2023-05-25 | 2023-05-31 | Code Drafting PM |  | Regulatory |  | 5.0 | Andrew Margan | Regulatory | Complete | COMPLETE |  |  |  |  |
| 2118 | 1.7.1.2.5.2 | Code Drafting (offline) |  | 55d | 2023-06-01 A | 2023-08-16 A | 2111SS+1d | 100% | 2023-06-01 | 2023-08-16 | 55d | 2023-06-01 | 2023-08-16 | Code Bodies,SRO Design | Code Drafting PM | Regulatory |  | 5.0 | Andrew Margan | Regulatory | Complete | COMPLETE |  |  |  |  |
| 2119 | 1.7.1.2.5.3 | Internal review and cross-checking of drafting across code drafters |  | 45d | 2023-06-15 A | 2023-08-16 A | 2118SS+10d | 100% | 2023-06-15 | 2023-08-16 | 45d | 2023-06-15 | 2023-08-16 | Code Bodies,SRO Design | Code Drafting PM | Regulatory |  | 5.0 | Andrew Margan | Regulatory | Complete | COMPLETE |  |  |  |  |
| 2120 | 1.7.1.2.5.4 | External industry review via consultation |  | 15d | 2023-08-18 A | 2023-09-07 A | 2119FS+1d | 100% | 2023-08-18 | 2023-09-07 | 15d | 2023-08-18 | 2023-09-07 | PP | Code Drafting PM | Regulatory |  | 5.0 | Andrew Margan | Regulatory | Complete | COMPLETE |  |  |  |  |
| 2121 | 1.7.1.2.5.5 | Triage and action comments |  | 19d | 2023-09-06 A | 2023-10-02 A | 2120FS-2d | 100% | 2023-09-06 | 2023-10-02 | 19d | 2023-09-06 | 2023-10-02 | Code Bodies,SRO Design | Code Drafting PM | Regulatory |  | 5.0 | Andrew Margan | Regulatory | Complete | COMPLETE |  |  |  |  |
| 2122 | 1.7.1.2.5.6 | CDWG review |  | 31d | 2023-10-03 A | 2023-11-14 A | 2121 | 100% | 2023-10-03 | 2023-11-14 | 31d | 2023-10-03 | 2023-11-06 | PP | Code Drafting PM | Regulatory |  | 5.0 | Andrew Margan | Regulatory | Complete | COMPLETE |  |  |  |  |
| 2123 | 1.7.1.2.5.7 | CCAG review |  | 6d | 2023-11-15 A | 2023-11-22 A | 2122 | 100% | 2023-11-15 | 2023-11-22 | 6d | 2023-11-07 | 2023-11-13 | PP |  | Regulatory |  | 5.0 | Andrew Margan | Regulatory | Complete | COMPLETE |  |  |  |  |
| 2124 | 1.7.1.2.5.8 | Code drafting for Governance and Qualification topic areas approved | milestone | 0d | 2023-11-22 A | 2023-11-22 A | 2123 | 100% | 2023-11-22 | 2023-11-22 | 0d | 2023-11-13 | 2023-11-13 | PP | Code Drafting PM | Regulatory |  | 5.12 | Andrew Margan | Regulatory | Complete | COMPLETE | MHHS-ART060 | T3-RE-0300 | CCAG | T2 |
| 2125 | 1.7.1.2.6 | **Interfaces / Data Specification (REC driven)** |  | 174d | 2023-05-25 A | 2024-01-23 A |  | 100% | 2023-05-25 | 2024-01-23 | 175d | 2023-05-25 | 2023-11-13 | N/A | N/A | Regulatory | M6 | 5.2 | N/A | Regulatory |  |  |  |  |  |  |
| 2126 | 1.7.1.2.6.1 | Pre Code Drafting activities |  | 5d | 2023-05-25 A | 2023-05-31 A | 2127SS-5d | 100% | 2023-05-25 | 2023-05-31 | 5d | 2023-05-25 | 2023-05-31 | Code Drafting PM |  | Regulatory |  | 5.0 | Andrew Margan | Regulatory | Complete | COMPLETE |  |  |  |  |
| 2127 | 1.7.1.2.6.2 | Code Drafting (offline) |  | 94d | 2023-06-01 A | 2023-10-10 A | 2111SS+1d | 100% | 2023-06-01 | 2023-10-10 | 94d | 2023-06-01 | 2023-08-16 | Code Bodies,SRO Design | Code Drafting PM | Regulatory |  | 5.2 | Andrew Margan | Regulatory | Complete | COMPLETE |  |  |  |  |
| 2128 | 1.7.1.2.6.3 | Internal review and cross-checking of drafting across code drafters |  | 84d | 2023-06-15 A | 2023-10-10 A | 2127SS+10d | 100% | 2023-06-15 | 2023-10-10 | 84d | 2023-06-15 | 2023-08-16 | Code Bodies,SRO Design | Code Drafting PM | Regulatory |  | 5.2 | Andrew Margan | Regulatory | Complete | COMPLETE |  |  |  |  |
| 2129 | 1.7.1.2.6.4 | External industry review via consultation |  | 15d | 2023-10-11 A | 2023-10-31 A | 2128 | 100% | 2023-10-11 | 2023-10-31 | 15d | 2023-08-18 | 2023-09-07 | PP | Code Drafting PM | Regulatory |  | 5.2 | Andrew Margan | Regulatory | Complete | COMPLETE |  |  |  |  |
| 2130 | 1.7.1.2.6.5 | Triage and action comments |  | 20d | 2023-10-30 A | 2023-11-24 A | 2129FS-2d | 100% | 2023-10-30 | 2023-11-24 | 20d | 2023-09-06 | 2023-10-02 | Code Bodies,SRO Design | Code Drafting PM | Regulatory |  | 5.2 | Andrew Margan | Regulatory | Complete | COMPLETE |  |  |  |  |
| 2131 | 1.7.1.2.6.6 | CDWG review |  | 37d | 2023-11-27 A | 2024-01-16 A | 2130 | 100% | 2023-11-27 | 2024-01-16 | 32d | 2023-10-03 | 2023-11-06 | PP | Code Drafting PM | Regulatory |  | 5.2 | Andrew Margan | Regulatory | Complete | COMPLETE |  |  |  |  |
| 2132 | 1.7.1.2.6.7 | CCAG review |  | 5d | 2024-01-17 A | 2024-01-23 A | 2131 | 100% | 2024-01-17 | 2024-01-23 | 11d | 2023-11-07 | 2023-11-13 | PP | Code Drafting PM | Regulatory |  | 5.2 | Andrew Margan | Regulatory | Complete | COMPLETE |  |  |  |  |
| 2133 | 1.7.1.2.6.8 | Code drafting for Interfaces / Data Specification topic areas approved | milestone | 0d | 2024-01-23 A | 2024-01-23 A | 2132 | 100% | 2024-01-23 | 2024-01-23 | 0d | 2023-11-13 | 2023-11-13 | PP | Code Drafting PM | Regulatory |  | 5.16 | Andrew Margan | Regulatory | Complete | COMPLETE | MHHS-ART060 | T3-RE-0350 | CCAG | T2 |
| 2134 | 1.7.1.2.7 | **Migration (BSC & REC driven)** |  | 130d | 2023-05-25 A | 2023-11-22 A |  | 100% | 2023-05-25 | 2023-11-22 | 130d | 2023-05-25 | 2023-11-13 | N/A | N/A | Regulatory | M6 | 5.0 | N/A | Regulatory |  |  |  |  |  |  |
| 2135 | 1.7.1.2.7.1 | Pre Code Drafting activities |  | 5d | 2023-05-25 A | 2023-05-31 A | 2136SS-5d | 100% | 2023-05-25 | 2023-05-31 | 5d | 2023-05-25 | 2023-05-31 | Code Drafting PM |  | Regulatory |  | 5.0 | Andrew Margan | Regulatory | Complete | COMPLETE |  |  |  |  |
| 2136 | 1.7.1.2.7.2 | Code Drafting (offline) |  | 55d | 2023-06-01 A | 2023-08-16 A | 2111SS+1d | 100% | 2023-06-01 | 2023-08-16 | 55d | 2023-06-01 | 2023-08-16 | Code Bodies,SRO Design | Code Drafting PM | Regulatory |  | 5.0 | Andrew Margan | Regulatory | Complete | COMPLETE |  |  |  |  |
| 2137 | 1.7.1.2.7.3 | Internal review and cross-checking of drafting across code drafters |  | 45d | 2023-06-15 A | 2023-08-16 A | 2136SS+10d | 100% | 2023-06-15 | 2023-08-16 | 45d | 2023-06-15 | 2023-08-16 | Code Bodies,SRO Design | Code Drafting PM | Regulatory |  | 5.0 | Andrew Margan | Regulatory | Complete | COMPLETE |  |  |  |  |
| 2138 | 1.7.1.2.7.4 | External industry review via consultation |  | 15d | 2023-08-18 A | 2023-09-07 A | 2137FS+1d | 100% | 2023-08-18 | 2023-09-07 | 15d | 2023-08-18 | 2023-09-07 | PP | Code Drafting PM | Regulatory |  | 5.0 | Andrew Margan | Regulatory | Complete | COMPLETE |  |  |  |  |
| 2139 | 1.7.1.2.7.5 | Triage and action comments |  | 19d | 2023-09-06 A | 2023-10-02 A | 2138FS-2d | 100% | 2023-09-06 | 2023-10-02 | 19d | 2023-09-06 | 2023-10-02 | Code Bodies,SRO Design | Code Drafting PM | Regulatory |  | 5.0 | Andrew Margan | Regulatory | Complete | COMPLETE |  |  |  |  |
| 2140 | 1.7.1.2.7.6 | CDWG review |  | 31d | 2023-10-03 A | 2023-11-14 A | 2139 | 100% | 2023-10-03 | 2023-11-14 | 31d | 2023-10-03 | 2023-11-06 | PP | Code Drafting PM | Regulatory |  | 5.0 | Andrew Margan | Regulatory | Complete | COMPLETE |  |  |  |  |
| 2141 | 1.7.1.2.7.7 | CCAG review |  | 6d | 2023-11-15 A | 2023-11-22 A | 2140 | 100% | 2023-11-15 | 2023-11-22 | 6d | 2023-11-07 | 2023-11-13 | PP | Code Drafting PM | Regulatory |  | 5.0 | Andrew Margan | Regulatory | Complete | COMPLETE |  |  |  |  |
| 2142 | 1.7.1.2.7.8 | Code drafting for Migration topic area approved | milestone | 0d | 2023-11-22 A | 2023-11-22 A | 2141 | 100% | 2023-11-22 | 2023-11-22 | 0d | 2023-11-13 | 2023-11-13 | PP | Code Drafting PM | Regulatory |  | 5.12 | Andrew Margan | Regulatory | Complete | COMPLETE | MHHS-ART060 | T3-RE-0400 | CCAG | T2 |

| ID | WBS | Task | Type | Duration | Start | Finish | Predecessors | Complete | Baseline start | Baseline finish | Baseline duration | Baseline 1 start | Baseline 1 finish | Constraint | Baseline cost | Responsible | Involved | Text9 | Update Version | MHHS Resource Name | MHHS Programme Phase | Sched Status | RAG | Task Status | Artefact ID | Milestone ID | Text29 | Tier |
| --- | --- | --- | --- | --- | --- | --- | --- | --- | --- | --- | --- | --- | --- | --- | --- | --- | --- | --- | --- | --- | --- | --- | --- | --- | --- | --- | --- | --- |
| 2143 | 1.7.1.2.8 | **Consequential Code Change** |  | 109d | 2023-10-11 A | 2024-03-11 A |  | 100% | 2023-10-11 | 2024-03-11 | 108d | 2023-08-18 | 2024-03-08 |  | -0 | N/A | N/A | Regulatory | 5.0 | N/A | Regulatory |  |  |  |  |  |  |  |
| 2144 | 1.7.1.2.8.1 | External industry review via consultation - drop 1 (DCUSA) |  | 15d | 2023-10-11 A | 2023-10-31 A | 2150SS | 100% | 2023-10-11 | 2023-10-31 | 15d | 2023-08-18 | 2023-09-07 |  |  | Code Bodies | PP | Regulatory | 5.2 | Andrew Margan | Regulatory | Complete | COMPLETE |  |  |  |  |  |
| 2145 | 1.7.1.2.8.2 | External industry review via consultation - drop 2 (Elexon) |  | 16d | 2024-02-19 A | 2024-03-11 A | 2160SS | 100% | 2024-02-19 | 2024-03-11 | 15d | 2023-10-16 | 2023-11-03 | start no earlier than 2024-02-19 |  | Code Bodies | PP | Regulatory | 5.2 | Andrew Margan | Regulatory | Complete | COMPLETE |  |  |  |  |  |
| 2146 | 1.7.1.2.9 | **Transition Text (all codes)** |  | 118d | 2023-08-11 A | 2024-01-23 A |  | 100% | 2023-08-11 | 2024-01-23 | 119d | 2023-08-11 | 2024-01-25 |  |  | N/A | N/A | Regulatory | 5.2 | N/A | Regulatory |  |  | M6 |  |  |  |  |
| 2147 | 1.7.1.2.9.1 | Pre Code Drafting activities |  | 8d | 2023-08-11 A | 2023-08-22 A | 2148SS-5d | 100% | 2023-08-11 | 2023-08-22 | 8d | 2023-08-11 | 2023-08-17 |  |  | Code Drafting PM |  | Regulatory | 5.0 | Andrew Margan | Regulatory | Complete | COMPLETE |  |  |  |  |  |
| 2148 | 1.7.1.2.9.2 | Code Drafting (offline) |  | 38d | 2023-08-18 A | 2023-10-10 A | 2138SS | 100% | 2023-08-18 | 2023-10-10 | 38d | 2023-08-18 | 2023-10-12 |  |  | Code Bodies,SRO Design | Code Drafting PM | Regulatory | 5.2 | Andrew Margan | Regulatory | Complete | COMPLETE |  |  |  |  |  |
| 2149 | 1.7.1.2.9.3 | Internal review and cross-checking of drafting across code drafters |  | 28d | 2023-09-01 A | 2023-10-10 A | 2148SS+10d | 100% | 2023-09-01 | 2023-10-10 | 28d | 2023-09-01 | 2023-10-12 |  |  | Code Bodies,SRO Design | Code Drafting PM | Regulatory | 5.2 | Andrew Margan | Regulatory | Complete | COMPLETE |  |  |  |  |  |
| 2150 | 1.7.1.2.9.4 | External industry review via consultation |  | 15d | 2023-10-11 A | 2023-10-31 A | 2149 | 100% | 2023-10-11 | 2023-10-31 | 15d | 2023-10-16 | 2023-11-03 |  |  | PP | Code Drafting PM | Regulatory | 5.2 | Andrew Margan | Regulatory | Complete | COMPLETE |  |  |  |  |  |
| 2151 | 1.7.1.2.9.5 | Triage and action comments |  | 20d | 2023-10-30 A | 2023-11-24 A | 2150FS-2d | 100% | 2023-10-30 | 2023-11-24 | 20d | 2023-11-02 | 2023-11-21 |  |  | Code Bodies,SRO Design | Code Drafting PM | Regulatory | 5.2 | Andrew Margan | Regulatory | Complete | COMPLETE |  |  |  |  |  |
| 2152 | 1.7.1.2.9.6 | CDWG review |  | 37d | 2023-11-27 A | 2024-01-16 A | 2151 | 100% | 2023-11-27 | 2024-01-16 | 37d | 2023-11-22 | 2024-01-17 |  |  | PP | Code Drafting PM | Regulatory | 5.2 | Andrew Margan | Regulatory | Complete | COMPLETE |  |  |  |  |  |
| 2153 | 1.7.1.2.9.7 | CCAG review |  | 5d | 2024-01-17 A | 2024-01-23 A | 2152 | 100% | 2024-01-17 | 2024-01-23 | 6d | 2024-01-18 | 2024-01-25 |  |  | PP | Code Drafting PM | Regulatory | 5.2 | Andrew Margan | Regulatory | Complete | COMPLETE |  |  |  |  |  |
| 2154 | 1.7.1.2.9.8 | Code drafting for Transition Text topic area approved | milestone | 0d | 2024-01-23 A | 2024-01-23 A | 2153 | 100% | 2024-01-23 | 2024-01-23 | 0d | 2024-01-25 | 2024-01-25 |  |  | PP | Code Drafting PM | Regulatory | 5.16 | Andrew Margan | Regulatory | Complete | COMPLETE |  | MHHS-ART060 | T3-RE-0450 | CCAG | T2 |
| 2155 | 1.7.1.2.10 | **Final Code Drafting (mop-up) (all codes)** |  | 199d | 2023-08-18 A | 2024-05-22 A |  | 100% | 2023-08-18 | 2024-05-22 | 199d | 2023-08-18 | 2024-05-13 |  |  | N/A | N/A | Regulatory | 5.0 | N/A | Regulatory |  |  | M6 |  |  |  |  |
| 2156 | 1.7.1.2.10.1 | Forward look and confirm remaining plan |  | 15d | 2023-08-18 A | 2023-09-07 A | 2148SS | 100% | 2023-08-18 | 2023-09-07 | 15d | 2023-08-18 | 2023-09-07 |  |  | Code Drafting PM |  | Regulatory | 5.0 | Andrew Margan | Regulatory | Complete | COMPLETE |  |  |  |  |  |
| 2157 | 1.7.1.2.10.2 | Identify remaining or additional areas of code (e.g. consequential change requirements) to be completed |  | 15d | 2023-08-18 A | 2023-09-07 A | 2156SS | 100% | 2023-08-18 | 2023-09-07 | 15d | 2023-08-18 | 2023-09-07 |  |  | Code Bodies,SRO Design | Code Drafting PM | Regulatory | 5.0 | Andrew Margan | Regulatory | Complete | COMPLETE |  |  |  |  |  |
| 2158 | 1.7.1.2.10.3 | Code Drafting (offline) Interim Consultation (1) |  | 60d | 2023-09-08 A | 2023-11-30 A | 2157 | 100% | 2023-09-08 | 2023-11-30 | 60d | 2023-09-08 | 2024-02-15 |  |  | Code Bodies,SRO Design | Code Drafting PM | Regulatory | 5.0 | Andrew Margan | Regulatory | Complete | COMPLETE |  |  |  |  |  |
| 2159 | 1.7.1.2.10.4 | Internal review and cross-checking of drafting across code drafters Interim Consultation (1) |  | 50d | 2023-09-22 A | 2023-11-30 A | 2158SS+10d | 100% | 2023-09-22 | 2023-11-30 | 50d | 2023-09-22 | 2024-02-15 |  |  | Code Bodies,SRO Design | Code Drafting PM | Regulatory | 5.0 | Andrew Margan | Regulatory | Complete | COMPLETE |  |  |  |  |  |
| 2160 | 1.7.1.2.10.5 | External industry review via consultation Interim Consultation (1) |  | 23d | 2023-12-01 A | 2024-01-02 A | 2159 | 100% | 2023-12-01 | 2024-01-02 | 23d | 2024-02-19 | 2024-03-08 |  |  | PP | Code Drafting PM | Regulatory | 5.0 | Andrew Margan | Regulatory | Complete | COMPLETE |  |  |  |  |  |
| 2161 | 1.7.1.2.10.6 | Code Drafting (offline) Final Consultation (2) |  | 55d | 2023-12-01 A | 2024-02-15 A | 2159 | 100% | 2023-12-01 | 2024-02-15 | 55d | 2023-09-08 | 2024-02-15 |  |  | Code Bodies,SRO Design | Code Drafting PM | Regulatory | 5.0 | Andrew Margan | Regulatory | Complete | COMPLETE |  |  |  |  |  |
| 2162 | 1.7.1.2.10.7 | Internal review and cross-checking of drafting across code drafters Final Consultation (2) |  | 45d | 2023-12-15 A | 2024-02-15 A | 2161SS+10d | 100% | 2023-12-15 | 2024-02-15 | 45d | 2023-09-22 | 2024-02-15 |  |  | Code Bodies,SRO Design | Code Drafting PM | Regulatory | 5.0 | Andrew Margan | Regulatory | Complete | COMPLETE |  |  |  |  |  |
| 2163 | 1.7.1.2.10.8 | External industry review via consultation Final Consultation (2) |  | 16d | 2024-02-19 A | 2024-03-11 A | 2162FS+1d | 100% | 2024-02-19 | 2024-03-11 | 15d | 2024-02-19 | 2024-03-08 |  |  | PP | Code Drafting PM | Regulatory | 5.0 | Andrew Margan | Regulatory | Complete | COMPLETE |  |  |  |  |  |
| 2164 | 1.7.1.2.10.9 | Triage and action comments |  | 18d | 2024-03-11 A | 2024-04-03 A | 2163FS-1d | 100% | 2024-03-11 | 2024-04-03 | 18d | 2024-03-07 | 2024-04-03 |  |  | Code Bodies,SRO Design | Code Drafting PM | Regulatory | 5.0 | Andrew Margan | Regulatory | Complete | COMPLETE |  |  |  |  |  |
| 2165 | 1.7.1.2.10.10 | CDWG review |  | 29d | 2024-04-04 A | 2024-05-14 A | 2164 | 100% | 2024-04-04 | 2024-05-14 | 31d | 2024-04-04 | 2024-05-03 |  |  | PP | Code Drafting PM | Regulatory | 5.0 | Andrew Margan | Regulatory | Complete | COMPLETE |  |  |  |  |  |
| 2166 | 1.7.1.2.10.11 | CCAG review |  | 6d | 2024-05-15 A | 2024-05-22 A | 2165 | 100% | 2024-05-15 | 2024-05-22 | 6d | 2024-05-06 | 2024-05-13 |  |  | PP | Code Drafting PM | Regulatory | 5.0 | Andrew Margan | Regulatory | Complete | COMPLETE |  |  |  |  |  |
| 2167 | 1.7.1.2.10.12 | Final code drafting (mop-up) approved | milestone | 0d | 2024-05-22 A | 2024-05-22 A | 2166 | 100% | 2024-05-22 | 2024-05-22 | 0d | 2024-05-13 | 2024-05-13 |  |  | PP | Code Drafting PM | Regulatory | 5.25 | Andrew Margan | Regulatory | Complete | COMPLETE |  | MHHS-ART060 | T3-RE-0500 | CCAG | T2 |

Notes:
- 2148: Guidance: 14/8/23 - RECCo transition drafting activity is expected to take the full 38 days, noting BSE co-drafting will be expected to take approx. 21 days

| ID | WBS | Task | Type | Duration | Start | Finish | Predecessors | Complete | Remaining | Baseline start | Baseline finish | Baseline duration | Baseline 1 start | Baseline 1 finish | Total slack | Free slack | Baseline cost | Responsible | Involved | Text9 | Task Status | Update Version | MHHS Resource Name | MHHS Programme Phase | Sched Status | RAG | Artefact ID | Milestone ID | Text29 | Tier |
| --- | --- | --- | --- | --- | --- | --- | --- | --- | --- | --- | --- | --- | --- | --- | --- | --- | --- | --- | --- | --- | --- | --- | --- | --- | --- | --- | --- | --- | --- | --- |
| 2168 | 1.7.1.2.11 | **Final code review, consistency check and approval** |  | 100d | 2024-04-04 A | 2024-08-21 A |  | 100% |  | 2024-04-04 | 2024-08-21 | 102d | 2024-05-06 | 2024-08-23 |  |  | -0 | N/A | N/A | Regulatory | M6 | 5.0 | N/A | Regulatory |  |  |  |  |  |  |
| 2169 | 1.7.1.2.11.1 | Gap analysis of final code against design artefacts (reverse process to code drafting) |  | 38d | 2024-04-04 A | 2024-05-27 A | 2165SS | 100% |  | 2024-04-04 | 2024-05-27 | 38d | 2024-05-06 | 2024-05-17 |  |  |  | Code Bodies,SRO Design | Code Drafting PM | Regulatory |  | 5.0 | Andrew Margan | Regulatory | Complete | COMPLETE |  |  |  |  |
| 2170 | 1.7.1.2.11.2 | Outputs of gap analysis actioned offline |  | 11d | 2024-05-28 A | 2024-06-11 A | 2169 | 100% |  | 2024-05-28 | 2024-06-11 | 11d | 2024-05-20 | 2024-06-07 |  |  |  | Code Bodies,SRO Design | Code Drafting PM | Regulatory |  | 5.0 | Andrew Margan | Regulatory | Complete | COMPLETE |  |  |  |  |
| 2171 | 1.7.1.2.11.3 | Final documentation collated for final consultation |  | 8d | 2024-06-12 A | 2024-06-21 A | 2170 | 100% |  | 2024-06-12 | 2024-06-21 | 9d | 2024-06-10 | 2024-06-13 |  |  |  | Code Drafting PM | Code Bodies,SRO Design | Regulatory |  | 5.23 | Andrew Margan | Regulatory | Complete | COMPLETE |  |  |  |  |
| 2172 | 1.7.1.2.11.4 | External industry review via consultation |  | 15d | 2024-06-24 A | 2024-07-12 A | 2171 | 100% |  | 2024-06-24 | 2024-07-12 | 20d | 2024-06-14 | 2024-07-04 |  |  |  | PP | Code Drafting PM | Regulatory |  | 5.0 | Andrew Margan | Regulatory | Complete | COMPLETE |  |  |  |  |
| 2173 | 1.7.1.2.11.5 | Triage and action comments |  | 10d | 2024-07-15 A | 2024-07-26 A | 2172 | 100% |  | 2024-07-15 | 2024-07-26 | 13d | 2024-07-03 | 2024-07-19 |  |  |  | Code Bodies,SRO Design | Code Drafting PM | Regulatory |  | 5.0 | Andrew Margan | Regulatory | Complete | COMPLETE |  |  |  |  |
| 2174 | 1.7.1.2.11.6 | Final CDWG review |  | 8d | 2024-08-02 A | 2024-08-13 A | 2173FS+4d | 100% |  | 2024-08-02 | 2024-08-13 | 6d | 2024-07-22 | 2024-08-16 |  |  |  | PP | Code Drafting PM | Regulatory |  | 5.0 | Andrew Margan | Regulatory | Complete | COMPLETE |  |  |  |  |
| 2175 | 1.7.1.2.11.7 | Final CCAG review |  | 6d | 2024-08-14 A | 2024-08-21 A | 2174 | 100% |  | 2024-08-14 | 2024-08-21 | 8d | 2024-08-19 | 2024-08-23 |  |  |  | PP | Code Drafting PM | Regulatory |  | 5.0 | Andrew Margan | Regulatory | Complete | COMPLETE |  |  |  |  |
| 2176 | 1.7.1.2.11.8 | CCAG recommend final code to PSG for baselining | milestone | 0d | 2024-08-21 A | 2024-08-21 A | 2175 | 100% |  | 2024-08-21 | 2024-08-21 | 0d | 2024-08-23 | 2024-08-23 |  |  |  | PP | Code Drafting PM | Regulatory |  | 5.9 | Andrew Margan | Regulatory | Complete | COMPLETE | MHHS-ART060 | T3-RE-0550 | CCAG | T2 |
| 2177 | 1.7.1.3 | Code changes baselined (M6) | milestone | 0d | 2024-08-23 A | 2024-08-23 A | 2175FS+2d, 2167, 2154, 2142, 2133, 2124, 2115, 2106, 2097, 2088 | 100% |  | 2024-08-23 | 2024-08-23 | 0d | 2024-08-23 | 2024-08-23 |  |  |  | CPT | PP | Regulatory |  | 5.0 | Andrew Margan | Regulatory | Complete | COMPLETE | MHHS-ART012 | T1-RE-1000 | PSG | T1 |
| 2178 | 1.7.2 | **Ofgem preparation and enactment of SCR powers** |  | 225d | 2024-02-05 A | 2024-12-13 |  | 86% | 31.4d | 2024-02-05 | 2024-12-13 | 225d | 2024-01-26 | 2024-11-12 | 789d |  | -0 | N/A | N/A | Regulatory | M7 | 5.0 | N/A | Regulatory |  |  |  |  |  |  |
| 2179 | 1.7.2.1 | **Preparation and enactment of SCR Powers** |  | 223d | 2024-02-05 A | 2024-12-11 |  | 87% | 29.44d | 2024-02-05 | 2024-12-11 | 223d | 2024-01-26 | 2024-11-11 | 726d |  | -0 | N/A | N/A | Regulatory |  | 5.0 | N/A | Regulatory |  |  |  |  |  |  |
| 2180 | 1.7.2.1.1 | Ofgem to keep Ofgem legal informed of process followed and nature of Code drafting to ensure that prepared for SCR go/no go decision |  | 101d | 2024-02-05 A | 2024-06-24 A | 2181SF | 100% |  | 2024-02-05 | 2024-06-24 | 101d | 2024-01-26 | 2024-06-14 |  |  |  | Ofgem | Code Bodies | Regulatory |  | 5.0 | Andrew Margan | Regulatory | Complete | COMPLETE |  |  |  |  |
| 2181 | 1.7.2.1.2 | OFGEM Legal to review Code Artefacts deliver policy intent and process followed and confirm that SCR powers are appropriate to use rather than SMAP - SCR go/no go |  | 14d | 2024-06-24 A | 2024-07-11 A | 2172SS | 100% |  | 2024-06-24 | 2024-07-11 | 15d | 2024-06-14 | 2024-07-04 |  |  |  | Ofgem | Code Bodies | Regulatory |  | 5.0 | Andrew Margan | Regulatory | Complete | COMPLETE |  |  |  |  |
| 2182 | 1.7.2.1.3 | Code Bodies to draft MOD proposal forms |  | 20d | 2024-07-12 A | 2024-08-08 A | 2181 | 100% |  | 2024-07-12 | 2024-08-08 | 20d | 2024-07-05 | 2024-08-01 |  |  |  | Code Bodies | Ofgem | Regulatory |  | 5.0 | Andrew Margan | Regulatory | Complete | COMPLETE |  |  |  |  |
| 2183 | 1.7.2.1.4 | Ofgem discuss and agree code mod timetable with code bodies (and MHHSP in relation to the dates for expected decisions) |  | 20d | 2024-07-12 A | 2024-08-08 A | 2181 | 100% |  | 2024-07-12 | 2024-08-08 | 20d | 2024-07-05 | 2024-08-01 |  |  |  | Ofgem | Code Bodies | Regulatory |  | 5.0 | Andrew Margan | Regulatory | Complete | COMPLETE |  |  |  |  |
| 2184 | 1.7.2.1.5 | Ofgem to publish each Direction to each code body specifying the timetable for each modification |  | 1d | 2024-08-28 A | 2024-08-28 A | 2183FS+13d | 100% |  | 2024-08-28 | 2024-08-28 | 1d | 2024-08-28 | 2024-08-28 |  |  |  | Ofgem | Code Bodies | Regulatory |  | 5.0 | Andrew Margan | Regulatory | Complete | COMPLETE |  |  |  |  |
| 2185 | 1.7.2.1.6 | Formally submit (by separate email) Modification Proposal Forms and legal texts to each code body |  | 1d | 2024-08-28 A | 2024-08-28 A | 2183FS+13d | 100% |  | 2024-08-28 | 2024-08-28 | 1d | 2024-08-28 | 2024-08-28 |  |  |  | Ofgem | Code Bodies | Regulatory |  | 5.0 | Andrew Margan | Regulatory | Complete | COMPLETE |  |  |  |  |
| 2186 | 1.7.2.1.7 | Each Code Body publishes and issues Modification Proposal Forms |  | 3d | 2024-08-29 A | 2024-09-02 A | 2185, 2184 | 100% |  | 2024-08-29 | 2024-09-02 | 3d | 2024-08-29 | 2024-09-02 |  |  |  | Code Bodies | Ofgem | Regulatory |  | 5.0 | Andrew Margan | Regulatory | Complete | COMPLETE |  |  |  |  |
| 2187 | 1.7.2.1.8 | Each Code Body sends Modification Proposal Forms to Panel to approve Mod to go to consultation |  | 10d | 2024-09-03 A | 2024-09-16 A | 2186 | 100% |  | 2024-09-03 | 2024-09-16 | 10d | 2024-09-03 | 2024-09-16 |  |  |  | Code Bodies | Ofgem | Regulatory |  | 5.0 | Andrew Margan | Regulatory | Complete | COMPLETE |  |  |  |  |
| 2188 | 1.7.2.1.9 | Modification Proposal approved by Panel for Consultation |  | 1d | 2024-09-17 A | 2024-09-17 A | 2187 | 100% |  | 2024-09-17 | 2024-09-17 | 1d | 2024-09-17 | 2024-09-17 |  |  |  | Code Bodies | Ofgem | Regulatory |  | 5.0 | Andrew Margan | Regulatory | Complete | COMPLETE |  |  |  |  |
| 2189 | 1.7.2.1.10 | Draft Modification Report issued for consultation |  | 1d | 2024-09-18 A | 2024-09-18 A | 2188 | 100% |  | 2024-09-18 | 2024-09-18 | 1d | 2024-09-18 | 2024-09-18 |  |  |  | Code Bodies | Ofgem | Regulatory |  | 5.0 | Andrew Margan | Regulatory | Complete | COMPLETE |  |  |  |  |
| 2190 | 1.7.2.1.11 | Consultation Close-out for representations |  | 15d | 2024-09-19 A | 2024-10-09 A | 2189 | 100% |  | 2024-09-19 | 2024-10-09 | 15d | 2024-09-19 | 2024-10-09 |  |  |  | Code Bodies | Ofgem | Regulatory |  | 5.0 | Andrew Margan | Regulatory | Complete | COMPLETE |  |  |  |  |
| 2191 | 1.7.2.1.12 | Each Code Body reviews consultation response and drafts Modification Report |  | 10d | 2024-10-10 A | 2024-10-23 A | 2190 | 100% |  | 2024-10-10 | 2024-10-23 | 10d | 2024-10-10 | 2024-10-23 |  |  |  | Code Bodies | Ofgem | Regulatory |  | 5.0 | Andrew Margan | Regulatory | Complete | COMPLETE |  |  |  |  |
| 2192 | 1.7.2.1.13 | Final Modification Report sent to Panel for decision with recommendation to approve |  | 1d | 2024-10-24 A | 2024-10-24 | 2191 | 90% | 0.1d | 2024-10-24 | 2024-10-24 | 1d | 2024-10-24 | 2024-10-24 | 726d | 0d |  | Code Bodies | Ofgem | Regulatory |  | 6.11 | Andrew Margan | Regulatory | Green | RED |  |  |  |  |
| 2193 | 1.7.2.1.14 | Modification Panel decision |  | 1d | 2024-11-07 | 2024-11-07 | 2192FS+9d |  |  | 2024-11-07 | 2024-11-07 | 1d | 2024-11-07 | 2024-11-07 | 726d | 0d |  | Code Bodies | Ofgem | Regulatory | 7.33 | 6.11 | Andrew Margan | Regulatory | Green | GREEN |  |  |  |  |
| 2194 | 1.7.2.1.15 | Code Bodies Submit Final Modification/Change Reports |  | 1d | 2024-11-08 | 2024-11-08 | 2193 |  |  | 2024-11-08 | 2024-11-08 | 1d |  |  | 726d | 0d |  | Code Bodies | Ofgem | Regulatory | 8.33 | 6.11 | Andrew Margan |  | Green | GREEN |  |  |  |  |
| 2195 | 1.7.2.1.16 | Ofgem Reviews Final Modification/Change Reports |  | 10d | 2024-11-11 | 2024-11-22 | 2194 |  |  | 2024-11-11 | 2024-11-22 | 10d |  |  | 726d | 0d |  | Ofgem | Code Bodies | Regulatory | 11.33 | 6.11 | Andrew Margan |  | Green | GREEN |  |  |  |  |
| 2196 | 1.7.2.1.17 | Ofgem Drafts Decision/Direction Letters |  | 17d | 2024-11-18 | 2024-12-10 | 2195SS+5d |  |  | 2024-11-18 | 2024-12-10 | 17d |  |  | 726d | 0d |  | Ofgem | Code Bodies | Regulatory | 18.33 | 6.11 | Andrew Margan |  | Green | GREEN |  |  |  |  |
| 2197 | 1.7.2.1.18 | Ofgem Internally Signs Off the Decision/Direction Letters and Sends Them to the Code Bodies |  | 1d | 2024-12-11 | 2024-12-11 | 2196 |  |  | 2024-12-11 | 2024-12-11 | 1d |  |  | 726d | 0d |  | Ofgem | Code Bodies | Regulatory | 41.33 | 6.11 | Andrew Margan |  | Green | GREEN |  |  |  |  |
| 2198 | 1.7.2.2 | Ofgem decisions on M6 baselined code modification proposals (M7) | milestone | 0d | 2024-12-11 | 2024-12-11 | 2177, 2197 |  |  | 2024-12-11 | 2024-12-11 | 0d | 2024-11-11 | 2024-11-11 | 726d | 0d |  | CPT | PP | Regulatory | 41.71 | 6.11 | Andrew Margan | Regulatory | Green | GREEN | MHHS-ART012 | T2-RE-0600 | CCAG | T2 |
| 2199 | 1.7.2.3 | Ofgem Publishes the Decisions/Directions |  | 2d | 2024-12-12 | 2024-12-13 | 2198 |  |  | 2024-12-12 | 2024-12-13 | 2d |  |  | 789d |  |  | Ofgem | Code Bodies | Regulatory | 42.33 | 6.11 | Andrew Margan |  | Green | GREEN |  |  |  |  |

Notes:
- 2192: 28/10/24 - Code Bodies continue to lead on the SCR process and will be submitting their FMRs in due course.
- 2198: Guidance: 5/8/25 - CR no52 and going to PSG on 7/8/24. 21/8/24: Milestone name and date change approved at psg on 7/8/24

| ID | WBS | Task | Type | Duration | Start | Finish | Predecessors | Complete | Remaining | Baseline start | Baseline finish | Baseline duration | Baseline 1 start | Baseline 1 finish | Total slack | Free slack | Constraint | Baseline cost | Responsible | Involved | Text9 | Task Status | Update Version | MHHS Resource Name | MHHS Programme Phase | Sched Status | RAG | Artefact ID | Milestone ID | Text29 | Tier | Text3 |
| --- | --- | --- | --- | --- | --- | --- | --- | --- | --- | --- | --- | --- | --- | --- | --- | --- | --- | --- | --- | --- | --- | --- | --- | --- | --- | --- | --- | --- | --- | --- | --- | --- |
| 2200 | 1.7.3 | **Deliver MHHS Code Changes** |  | 292d | 2024-11-12 | 2025-12-24 |  |  |  | 2024-11-12 | 2025-12-24 | 149d | 2024-11-12 | 2025-03-07 | 521d |  |  |  | N/A | N/A | Regulatory | M8 | 6.11 | N/A | Regulatory |  |  |  |  |  |  |  |
| 2201 | 1.7.3.1 | **Releases** |  | 292d | 2024-11-12 | 2025-12-24 |  |  |  | 2024-11-12 | 2025-12-24 | 149d | 2024-11-12 | 2025-03-07 | 521d |  |  |  | N/A | N/A | Regulatory |  | 6.11 | N/A | Regulatory |  |  |  |  |  |  |  |
| 2202 | 1.7.3.1.1 | Impacted codes make resourcing provisions and prepare to implement new Code via internal code body change processes |  | 78d | 2024-11-12 | 2025-02-27 |  |  |  | 2024-11-12 | 2025-02-27 | 78d | 2024-11-12 | 2025-02-27 | 735d |  | start no earlier than 2024-11-12 |  | Code Bodies |  | Regulatory | 12.33 | 6.11 | Andrew Margan | Regulatory | Green | GREEN |  |  |  |  |  |
| 2203 | 1.7.3.1.2 | **Main Code Release** |  | 71d | 2025-09-17 | 2025-12-24 |  |  |  | 2025-09-17 | 2025-12-24 | 71d | 2025-02-28 | 2025-03-07 | 521d |  |  |  | N/A | N/A | Regulatory |  | 6.11 | N/A | Regulatory |  |  |  |  |  |  |  |
| 2204 | 1.7.3.1.2.1 | Release preparation (e.g. preparing release documentation) |  | 6d | 2025-09-17 | 2025-09-24 | 2205SF |  |  | 2025-09-17 | 2025-09-24 | 5d | 2025-02-28 | 2025-03-07 | 586d |  |  |  | Code Bodies |  | Regulatory | 321.33 | 6.11 | Andrew Margan | Regulatory | Green | GREEN |  |  |  |  |  |
| 2205 | 1.7.3.1.2.2 | Implement new code on day of code release | milestone | 0d | 2025-09-24 | 2025-09-24 | 2206SF |  |  | 2025-09-24 | 2025-09-24 | 1d | 2025-03-07 | 2025-03-07 | 586d | 0d |  |  | Code Bodies |  | Regulatory | 328.71 | 6.11 | Andrew Margan | Regulatory | Green | GREEN |  |  |  |  |  |
| 2206 | 1.7.3.1.2.3 | Code changes delivered (M8) | milestone | 0d | 2025-09-24 | 2025-09-24 | 2198, 2177, 1588SS |  |  | 2025-09-24 | 2025-09-24 | 0d | 2025-03-07 | 2025-03-07 | 521d | 0d |  |  | CPT | Code Bodies,PP | Regulatory | 328.71 | 6.11 | Andrew Margan | Regulatory | Green | GREEN | MHHS-ART060 | T2-RE-0650 | CCAG | T2 |  |
| 2207 | 1.7.3.1.2.4 | Code changes delivered (M8*) late exit | milestone | 0d | 2025-12-24 | 2025-12-24 | 2206FS+65d |  |  | 2025-12-24 | 2025-12-24 | 0d |  |  | 521d |  |  |  | CPT | Code Bodies,PP | Regulatory | 419.71 | 6.11 | Andrew Margan | Regulatory | Green | GREEN | MHHS-ART060 | T2-RE-0700 | CCAG | T2 |  |
| 2208 | 1.7.4 | **External Programme Dependency Management** |  | 38d | 2023-12-01 A | 2024-01-24 A |  | 100% |  | 2023-12-01 | 2024-01-24 | 38d | 2023-09-08 | 2024-01-24 |  |  |  |  | N/A | N/A | Regulatory |  | 5.0 | N/A | Regulatory |  |  |  |  |  |  |  |
| 2209 | 1.7.4.1 | **DCP397** |  | 38d | 2023-12-01 A | 2024-01-24 A |  | 100% |  | 2023-12-01 | 2024-01-24 | 38d | 2023-09-08 | 2024-01-24 |  |  |  |  | N/A | N/A | Regulatory |  | 5.0 | N/A | Regulatory |  |  |  |  |  |  |  |
| 2210 | 1.7.4.1.1 | Ensure DCP397 drafting included in mop-up code drafting activity (link to mop-up) |  | 20d | 2023-12-01 A | 2023-12-28 A | 2161SS, 2158SS | 100% |  | 2023-12-01 | 2023-12-28 | 20d | 2023-09-08 | 2023-10-05 |  |  |  |  | CPT | Code Bodies,SRO Design, Code Drafting PM | Regulatory |  | 5.0 | Andrew Margan | Regulatory | Complete | COMPLETE |  |  |  |  |  |
| 2211 | 1.7.4.1.2 | Implementation of DCP397 | milestone | 0d | 2024-01-24 A | 2024-01-24 A |  | 100% |  | 2024-01-24 | 2024-01-24 | 0d | 2024-01-24 | 2024-01-24 |  |  | start no earlier than 2024-01-24 |  | Code Bodies |  | Regulatory |  | 5.0 | Andrew Margan | Regulatory | Complete | COMPLETE |  |  |  |  |  |
| 2212 | 1.8 | **MIGRATION** |  | 1246d | 2022-10-31 A | 2027-08-09 |  | 38% | 776.29d | 2022-10-31 | 2027-08-09 | 1092d | 2022-10-31 | 2027-01-05 | 98d |  |  | -0 | N/A | N/A | Migration |  |  | N/A | Migration |  |  |  |  |  |  | 1 Oct 2024 - 31 Oct 2025 |
| 2213 | 1.8.1 | Migration Period Plan Review 1 Completed | milestone, inactive | 0d | 2025-01-31 | 2025-01-31 |  |  |  | 2025-01-31 | 2025-01-31 | 0d | 2025-01-31 | 2025-01-31 | 754d |  | finish no earlier than 2025-01-31 |  | SRO | PP,IPA | Migration | 92.71 | 5.28 | Simon chidwick | Migration |  | GREEN |  | T3-MI-0016 | MCAG (Migration) | T3 |  |
| 2214 | 1.8.2 | **Regulatory Governance** |  | 198d | 2024-04-01 A | 2025-01-01 |  | 47% | 105d | 2024-04-01 | 2025-01-01 | 173d |  |  | 776d |  |  | -0 | N/A | N/A | Migration |  | 5.28 | N/A |  |  |  |  |  |  |  |  |
| 2215 | 1.8.2.1 | Incentive Mods Created |  | 110d | 2024-04-01 A | 2024-08-30 |  | 85% | 17d | 2024-04-01 | 2024-08-30 | 85d |  |  | 776d | 0d | start no earlier than 2024-04-01 |  | SRO Migration | SRO Migration,Code Bodies,PP | Migration |  | 5.28 | Simon chidwick |  | Overdue | RED |  |  |  |  |  |
| 2216 | 1.8.2.2 | Incentives Implemented |  | 88d | 2024-09-02 | 2025-01-01 | 2215 |  |  | 2024-09-02 | 2025-01-01 | 88d |  |  | 776d |  | start no earlier than 2024-07-02 |  | Code Bodies | Code Bodies,SRO Migration | Migration | -58.67 | 5.28 | Simon chidwick |  | Overdue Start | GREEN |  |  |  |  |  |
| 2217 | 1.8.3 | **Migration Framework Agreed and Implemented** |  | 256d | 2024-02-01 A | 2025-01-23 |  | 62% | 97.34d | 2024-02-01 | 2025-01-23 | 214d |  |  | 672d |  |  | -0 | N/A | N/A | Migration |  | 5.28 | N/A |  |  |  |  |  |  |  |  |
| 2218 | 1.8.3.1 | **Consultation 1 - Schedule** |  | 70d | 2024-02-01 A | 2024-05-08 A |  | 100% |  | 2024-02-01 | 2024-05-08 | 70d |  |  |  |  |  |  | N/A | N/A | Migration |  | 5.28 | N/A |  |  |  |  |  |  |  |  |
| 2219 | 1.8.3.1.1 | Prepare Artefacts for Consultation |  | 33d | 2024-02-01 A | 2024-03-18 A |  | 100% |  | 2024-02-01 | 2024-03-18 | 33d |  |  |  |  |  |  |  |  | Migration |  | 5.28 | Simon chidwick |  | Complete | COMPLETE |  |  |  |  |  |
| 2220 | 1.8.3.1.2 | Industry Consultation |  | 16d | 2024-03-18 A | 2024-04-08 A |  | 100% |  | 2024-03-18 | 2024-04-08 | 16d |  |  |  |  |  |  |  |  | Migration |  | 5.28 | Simon chidwick |  | Complete | COMPLETE |  |  |  |  |  |
| 2221 | 1.8.3.1.3 | Triage and Action Comments |  | 10d | 2024-04-08 A | 2024-04-19 A |  | 100% |  | 2024-04-08 | 2024-04-19 | 10d |  |  |  |  |  |  |  |  | Migration |  | 5.28 | Simon chidwick |  | Complete | COMPLETE |  |  |  |  |  |
| 2222 | 1.8.3.1.4 | Industry Assurance Review |  | 6d | 2024-04-19 A | 2024-04-26 A |  | 100% |  | 2024-04-19 | 2024-04-26 | 6d |  |  |  |  |  |  |  |  | Migration |  | 5.28 | Simon chidwick |  | Complete | COMPLETE |  |  |  |  |  |
| 2223 | 1.8.3.1.5 | MWG Recommendation |  | 1d | 2024-04-26 A | 2024-04-26 A |  | 100% |  | 2024-04-26 | 2024-04-26 | 1d |  |  |  |  |  |  |  |  | Migration |  | 5.28 | Simon chidwick |  | Complete | COMPLETE |  |  |  |  |  |
| 2224 | 1.8.3.1.6 | MCAG Interim Approval Artefacts |  | 1d | 2024-05-08 A | 2024-05-08 A |  | 100% |  | 2024-05-08 | 2024-05-08 | 1d |  |  |  |  |  |  |  |  | Migration |  | 5.28 | Simon chidwick |  | Complete | COMPLETE |  |  |  |  |  |

Notes:
- 2213: 2/7: To go to July MCAG for removal because milestone no longer reflects the delivery of the migration approach / Action: 11/7/24: MI-0016 warren is saying he wants another think about before going to MCAG so can you hold off doing anything official with that one please?

| ID | WBS | Task | Type | Duration | Start | Finish | Predecessors | Complete | Remaining | Baseline start | Baseline finish | Baseline duration | Total slack | Free slack | Baseline cost | Responsible | Involved | Text9 | Update Version | MHHS Resource Name | Sched Status | RAG | Milestone ID | Text29 | Task Status |
| --- | --- | --- | --- | --- | --- | --- | --- | --- | --- | --- | --- | --- | --- | --- | --- | --- | --- | --- | --- | --- | --- | --- | --- | --- | --- |
| 2225 | 1.8.3.2 | **Consultation 2 - Control** |  | 79d | 2024-04-08 A | 2024-07-25 A |  | 100% |  | 2024-04-08 | 2024-07-25 | 79d |  |  | -0 | N/A | N/A | Migration | 5.28 | N/A |  |  |  |  |  |
| 2226 | 1.8.3.2.1 | Prepare Artefacts for Consultation |  | 49d | 2024-04-08 A | 2024-06-13 A |  | 100% |  | 2024-04-08 | 2024-06-13 | 49d |  |  |  |  |  | Migration | 5.28 | Simon chidwick | Complete | COMPLETE |  |  |  |
| 2227 | 1.8.3.2.2 | Industry Consultation |  | 11d | 2024-06-14 A | 2024-06-28 A | 2226 | 100% |  | 2024-06-14 | 2024-06-28 | 11d |  |  |  |  |  | Migration | 5.28 | Simon chidwick | Complete | COMPLETE |  |  |  |
| 2228 | 1.8.3.2.3 | Triage and Action Comments |  | 9d | 2024-07-01 A | 2024-07-11 A | 2227 | 100% |  | 2024-07-01 | 2024-07-11 | 9d |  |  |  | SRO Migration | SRO Migration | Migration | 5.28 | Simon chidwick | Complete | COMPLETE |  |  |  |
| 2229 | 1.8.3.2.4 | Industry Assurance Review |  | 5d | 2024-07-12 A | 2024-07-18 A | 2228 | 100% |  | 2024-07-12 | 2024-07-18 | 5d |  |  |  | PP | PP,SRO Migration | Migration | 5.28 | Simon chidwick | Complete | COMPLETE |  |  |  |
| 2230 | 1.8.3.2.5 | MWG Recommendation | milestone | 0d | 2024-07-18 A | 2024-07-18 A | 2229 | 100% |  | 2024-07-18 | 2024-07-18 | 0d |  |  |  | PP | PP,SRO Migration | Migration | 5.28 | Simon chidwick | Complete | COMPLETE |  |  |  |
| 2231 | 1.8.3.2.6 | Consultation 2 - Control - MCAG Approval of Interim Artefacts | milestone | 0d | 2024-07-25 A | 2024-07-25 A | 2230FS+5d | 100% |  | 2024-07-25 | 2024-07-25 | 0d |  |  |  | PP | PP,SRO Migration | Migration | 5.30 | Simon chidwick | Complete | COMPLETE | T3-MI-0037 | MCAG (Migration) |  |
| 2232 | 1.8.3.3 | **Consultation 3 - Parameters** |  | 143d | 2024-07-09 A | 2025-01-23 |  | 18% | 117.21d | 2024-07-09 | 2025-01-23 | 76d | 672d |  | -0 | N/A | N/A | Migration | 5.28 | N/A |  |  |  |  |  |
| 2233 | 1.8.3.3.1 | Prepare Artefacts (9) for Consultation |  | 95d | 2024-07-09 A | 2024-11-18 | 2240SS+6d | 23% | 73d | 2024-07-09 | 2024-11-18 | 36d | 672d | 0d |  | SRO Migration | SRO Migration | Migration | 5.28 | Simon chidwick | Green | RED |  |  |  |
| 2234 | 1.8.3.3.2 | Industry Consultation |  | 10d | 2024-11-19 | 2024-12-02 | 2233 |  |  | 2024-11-19 | 2024-12-02 | 10d | 672d | 0d |  | PP | PP,SRO Migration | Migration | 5.28 | Simon chidwick | Green | RED |  |  | 19.33 |
| 2235 | 1.8.3.3.3 | Triage and Action Comments |  | 10d | 2024-12-03 | 2024-12-16 | 2234 |  |  | 2024-12-03 | 2024-12-16 | 10d | 672d | 0d |  | SRO Migration | SRO Migration | Migration | 5.28 | Simon chidwick | Green | RED |  |  | 33.33 |
| 2236 | 1.8.3.3.4 | Industry Assurance Review |  | 7d | 2024-12-17 | 2024-12-25 | 2235 |  |  | 2024-12-17 | 2024-12-25 | 7d | 672d | 0d |  | PP | PP,SRO Migration | Migration | 5.28 | Simon chidwick | Green | RED |  |  | 47.33 |
| 2237 | 1.8.3.3.5 | MWG Recommendation | milestone | 0d | 2025-01-06 | 2025-01-06 | 2236FS+8d |  |  | 2025-01-06 | 2025-01-06 | 0d | 672d | 0d |  | PP | PP,SRO Migration | Migration | 5.28 | Simon chidwick | Green | RED |  |  | 67.71 |
| 2238 | 1.8.3.3.6 | MCAG Approval of Migration Framework Artefacts (Baselined) | milestone | 0d | 2025-01-23 | 2025-01-23 | 2241, 2237FS+13d |  |  | 2025-01-23 | 2025-01-23 | 0d | 672d | 0d |  | PP | PP,SRO Migration | Migration | 5.30 | Simon chidwick | Green | AMBER | T3-MI-0017 | MCAG (Migration) | 84.71 |
| 2239 | 1.8.4 | **Migration Schedule Agreed and Maintained** |  | 415d | 2024-07-01 A | 2026-01-30 |  | 41% | 246.53d | 2024-07-01 | 2026-01-30 | 207d | 494d |  | -0 | N/A | N/A | Migration | 5.28 | N/A |  |  |  |  |  |
| 2240 | 1.8.4.1 | Indicative Envelopes Issued |  | 23d | 2024-07-01 A | 2024-07-31 A | 2224FS+37d | 100% |  | 2024-07-01 | 2024-07-31 | 23d |  |  |  | SRO Migration | SRO Migration,PP | Migration | 5.28 | Simon chidwick | Complete | COMPLETE |  |  |  |
| 2241 | 1.8.4.2 | Supplier Submissions |  | 45d | 2024-08-01 A | 2024-10-02 A | 2240, 2231 | 100% |  | 2024-08-01 | 2024-10-02 | 45d |  |  |  | PP | SRO Migration,PP | Migration | 5.28 | Simon chidwick | Complete | COMPLETE |  |  |  |
| 2242 | 1.8.4.3 | Team Assess Responses |  | 10d | 2024-10-03 A | 2024-10-16 A | 2241 | 100% |  | 2024-10-03 | 2024-10-16 | 10d |  |  |  | SRO Migration | SRO Migration | Migration | 5.28 | Simon chidwick | Complete | COMPLETE |  |  |  |
| 2243 | 1.8.4.4 | Discuss and Agree Approach with Participants where necessary |  | 4d | 2024-10-17 A | 2024-10-22 A | 2242 | 100% |  | 2024-10-17 | 2024-10-22 | 4d |  |  |  | SRO Migration | SRO Migration,PP | Migration | 5.28 | Simon chidwick | Complete | COMPLETE |  |  |  |
| 2244 | 1.8.4.5 | V1.0 of Migration Schedule Baseline Approved at MCAG | milestone | 0d | 2025-01-10 | 2025-01-10 | 2253, 2243 |  |  | 2025-01-10 | 2025-01-10 | 0d | 494d | 0d |  | PP | SRO Migration,PP | Migration | 5.30 | Simon chidwick | Green | GREEN | T3-MI-0039 | MCAG (Migration) | 71.71 |
| 2245 | 1.8.4.6 | Sprint Planning (Cycle 1) |  | 40d | 2025-06-16 | 2025-08-08 | 2244FS+110d |  |  | 2025-06-16 | 2025-08-08 | 20d | 494d | 0d |  | SRO Migration | SRO Migration,PP | Migration | 5.28 | Simon chidwick | Green | GREEN |  |  | 228.33 |
| 2246 | 1.8.4.7 | Sprint Planning (Cycle 2) |  | 40d | 2025-09-15 | 2025-11-07 | 2245FS+25d |  |  | 2025-09-15 | 2025-11-07 | 20d | 494d | 0d |  | SRO Migration | SRO Migration,PP | Migration | 5.28 | Simon chidwick | Green | GREEN |  |  | 319.33 |
| 2247 | 1.8.4.8 | Sprint Planning (Cycle 3) |  | 40d | 2025-12-08 | 2026-01-30 | 2246FS+20d, 2261 |  |  | 2025-12-08 | 2026-01-30 | 19d | 494d |  |  | SRO Migration | SRO Migration,PP | Migration | 5.28 | Simon chidwick | Green | GREEN |  |  | 403.33 |
| 2248 | 1.8.5 | **Migration Control Centre Tooling** |  | 242d | 2024-05-09 A | 2025-04-11 |  | 66% | 81.56d | 2024-05-09 | 2025-04-11 | 182d | 663d |  |  | N/A | N/A | Migration | 5.28 | N/A |  |  |  |  |  |
| 2249 | 1.8.5.1 | Data Source Definition |  | 120d | 2024-05-09 A | 2024-10-23 A | 2224 | 100% |  | 2024-05-09 | 2024-10-23 | 60d |  |  |  | SRO Migration | SRO Migration | Migration | 5.28 | Simon chidwick | Complete | COMPLETE |  |  |  |
| 2250 | 1.8.5.2 | Scheduling and Data Requirements |  | 120d | 2024-05-09 A | 2024-10-23 A | 2224 | 100% |  | 2024-05-09 | 2024-10-23 | 60d |  |  |  | SRO Migration | SRO Migration | Migration | 5.28 | Simon chidwick | Complete | COMPLETE |  |  |  |
| 2251 | 1.8.5.3 | Tool Phase 1 |  | 11d | 2024-10-24 | 2024-11-07 | 2250, 2249 |  |  | 2024-10-24 | 2024-11-07 | 11d | 494d | 0d |  | SRO Migration | SRO Migration | Migration | 5.28 | Simon chidwick | Green | GREEN |  |  | -6.67 |
| 2252 | 1.8.5.4 | Data Requirements |  | 21d | 2024-11-08 | 2024-12-06 | 2224, 2251 |  |  | 2024-11-08 | 2024-12-06 | 21d | 494d | 0d |  | SRO Migration | SRO Migration | Migration | 5.28 | Simon chidwick | Green | GREEN |  |  | 8.33 |
| 2253 | 1.8.5.5 | Tool Phase 2 |  | 25d | 2024-12-09 | 2025-01-10 | 2252 |  |  | 2024-12-09 | 2025-01-10 | 25d | 494d | 0d |  | SRO Migration | SRO Migration | Migration | 5.28 | Simon chidwick | Green | GREEN |  |  | 39.33 |
| 2254 | 1.8.5.6 | Data Source Provision |  | 7d | 2025-01-13 | 2025-01-21 | 2253 |  |  | 2025-01-13 | 2025-01-21 | 7d | 663d | 0d |  | SRO Migration | SRO Migration | Migration | 5.28 | Simon chidwick | Green | GREEN |  |  | 74.33 |
| 2255 | 1.8.5.7 | Tool - Internal and External Testing |  | 58d | 2025-01-22 | 2025-04-11 | 2254 |  |  | 2025-01-22 | 2025-04-11 | 58d | 663d | 0d |  | SRO Migration | SRO Migration,PP | Migration | 5.28 | Simon chidwick | Green | GREEN |  |  | 83.33 |

Notes:
- 2231: New milestone added to reflect updated delivery approach for migration. To go to July MCAG for approval / Guidance: 25/7/24: New Milestone approved at MCAG on 25/7/24
- 2233: 29/10/24 - Red rating given because the consultation will take place in December. Exact date for this not yet set.
- 2234: 29/10/24 - Red rating given because the consultation will take place in December. Exact date for this not yet set.
- 2235: 29/10/24 - Red rating given because the consultation will take place in December. Exact date for this not yet set.
- 2236: 29/10/24 - Red rating given because the consultation will take place in December. Exact date for this not yet set.
- 2237: 29/10/24 - Red rating given because the consultation will take place in December. Exact date for this not yet set.
- 2238: 29/10/24 - Expected baseline date will change. This is due to a combination of the changes coming out of MWG for Consultation 3 being very minimal for the original release date of 28th August and not warranting an industry consultation, coupled with the reassessment of activity that has highlighted that it would be better to wait to align Consultation 3 with any changes that result from the current Supplier Migration Submission process, rather than issue a consultation before that process had completed and the MCC has digested the plans, and then have to issue yet further consultations. Current thinking is that the Consultation 3 would be issued in December and approved (and therefore the framework baselined) in January / February. / Guidance: 25/7/24: Milestone name and date change approved at MCAG on 25/7/24. Date from 2/8/24 to 22/10/24. Name from 'Migration Processes & Procedures approved' to 'MCAG Approval of Migration Framework Artefacts (Baselined)’
- 2244: On Track. / Guidance: 25/7/24: New Milestone approved at MCAG on 25/7/24
- 2247: Action: 8/7/24: Successor was on M10 (1861 id903) - I removed as it was moving the date out
- 2251: Action: 9/7/24: To be expanded once clarified
- 2252: Action: 9/7/24: To be expanded once clarified
- 2253: Action: 9/7/24: To be expanded once clarified
- 2254: Action: 9/7/24: To be expanded once clarified
- 2255: Action: 9/7/24: To be expanded once clarified

| ID | WBS | Task | Type | Duration | Start | Finish | Predecessors | Complete | Remaining | Baseline start | Baseline finish | Baseline duration | Baseline 1 start | Baseline 1 finish | Total slack | Free slack | Baseline cost | Responsible | Involved | Text9 | Update Version | MHHS Resource Name | Sched Status | RAG | Task Status | MHHS Programme Phase | Artefact ID | Milestone ID | Text29 | Tier |
| --- | --- | --- | --- | --- | --- | --- | --- | --- | --- | --- | --- | --- | --- | --- | --- | --- | --- | --- | --- | --- | --- | --- | --- | --- | --- | --- | --- | --- | --- | --- |
| 2256 | 1.8.6 | **Migration Control Centre Mobilised and Ready** |  | 185d | 2024-07-30 A | 2025-04-14 |  | 1% | 182.8d | 2024-07-30 | 2025-04-14 | 134d |  |  | 663d |  |  | N/A | N/A | Migration | 5.28 | N/A |  |  |  |  |  |  |  |  |
| 2257 | 1.8.6.1 | Migration Control Centre TOM Definition |  | 65d | 2024-07-30 A | 2024-10-28 | 2231FS+2d | 3% | 63d | 2024-07-30 | 2024-10-28 | 29d |  |  | 677d | 0d |  | SRO Migration | SRO Migration | Migration | 5.28 | Simon chidwick | Green | GREEN |  |  |  |  |  |  |
| 2258 | 1.8.6.2 | Access to Data |  | 25d | 2024-11-04 | 2024-12-06 | 2257FS+4d |  |  | 2024-11-04 | 2024-12-06 | 25d |  |  | 677d | 0d |  | SRO Migration | SRO Migration | Migration | 5.28 | Simon chidwick | Green | GREEN | 4.33 |  |  |  |  |  |
| 2259 | 1.8.6.3 | Migration Control Centre Delegation of Authority |  | 12d | 2024-12-24 | 2025-01-08 | 2258FS+11d |  |  | 2024-12-24 | 2025-01-08 | 12d |  |  | 677d | 0d |  | SRO Migration | SRO Migration | Migration | 5.28 | Simon chidwick | Green | GREEN | 54.33 |  |  |  |  |  |
| 2260 | 1.8.6.4 | Recruit and Train |  | 65d | 2024-12-24 | 2025-03-24 | 2259SS |  |  | 2024-12-24 | 2025-03-24 | 65d |  |  | 677d | 14d |  | SRO Migration | SRO Migration | Migration | 5.28 | Simon chidwick | Green | GREEN | 54.33 |  |  |  |  |  |
| 2261 | 1.8.6.5 | Dress Rehearsal |  | 1d | 2025-04-14 | 2025-04-14 | 2255, 2260, 2265, 2266 |  |  | 2025-04-14 | 2025-04-14 | 1d |  |  | 663d | 169d |  | SRO Migration | SRO Migration | Migration | 5.28 | Simon chidwick | Green | GREEN | 165.33 |  |  |  |  |  |
| 2262 | 1.8.7 | **PP's Prepared for Migration** |  | 196d | 2024-07-01 A | 2025-03-31 |  | 23% | 150.77d | 2024-07-01 | 2025-03-31 | 154d |  |  | 672d |  | -0 | N/A | N/A | Migration | 5.28 | N/A |  |  |  |  |  |  |  |  |
| 2263 | 1.8.7.1 | Prep for Envelope Webinar |  | 26d | 2024-07-01 A | 2024-08-05 A | 2240SS | 100% |  | 2024-07-01 | 2024-08-05 | 26d |  |  |  |  |  | SRO Migration | SRO Migration | Migration | 5.28 | Simon chidwick | Complete | COMPLETE |  |  |  |  |  |  |
| 2264 | 1.8.7.2 | Envelope/Submission Webinar |  | 1d | 2024-08-05 A | 2024-08-05 A | 2263FF | 100% |  | 2024-08-05 | 2024-08-05 | 1d |  |  |  |  |  | SRO Migration | SRO Migration,PP | Migration | 5.28 | Simon chidwick | Complete | COMPLETE |  |  |  |  |  |  |
| 2265 | 1.8.7.3 | Guides Creation |  | 45d | 2025-01-28 | 2025-03-31 | 2238FS+2d |  |  | 2025-01-28 | 2025-03-31 | 45d |  |  | 672d | 9d |  | SRO Migration | SRO Migration,PP | Migration | 5.28 | Simon chidwick | Green | GREEN | 89.33 |  |  |  |  |  |
| 2266 | 1.8.7.4 | Support Channels |  | 45d | 2025-01-28 | 2025-03-31 | 2238FS+2d |  |  | 2025-01-28 | 2025-03-31 | 45d |  |  | 672d | 9d |  | SRO Migration | SRO Migration,PP | Migration | 5.28 | Simon chidwick | Green | GREEN | 89.33 |  |  |  |  |  |
| 2267 | 1.8.8 | **Migration Artefact Development and Publication** |  | 773d | 2022-10-31 A | 2025-10-15 |  | 80% | 154.9d | 2022-10-31 | 2025-09-03 | 635d | 2022-10-31 | 2025-04-04 | 571d |  | -0 | N/A | N/A | Migration | 5.0 | N/A |  |  |  | Migration |  |  |  |  |
| 2268 | 1.8.8.1 | **Migration Approach** |  | 28d | 2022-10-31 A | 2022-12-07 A |  | 100% |  | 2022-10-31 | 2022-12-07 | 28d | 2022-10-31 | 2022-12-07 |  |  |  | N/A | N/A | Migration | 5.0 | N/A |  |  |  | Migration |  |  |  |  |
| 2269 | 1.8.8.1.1 | Option analysis (via MWG and PPIR) and recommendation |  | 23d | 2022-10-31 A | 2022-11-30 A |  | 100% |  | 2022-10-31 | 2022-11-30 | 23d | 2022-10-31 | 2022-11-30 |  |  |  | PP | SI Migration | Migration | 5.0 | John Wiggins,Matthew Breen | Complete | COMPLETE |  | Migration |  |  |  |  |
| 2270 | 1.8.8.1.2 | Migration Approach approved | milestone | 0d | 2022-12-07 A | 2022-12-07 A | 2269FS+5d | 100% |  | 2022-12-07 | 2022-12-07 | 0d | 2022-12-07 | 2022-12-07 |  |  |  | SI Migration | PP,IPA | Migration | 5.0 | John Wiggins,Matthew Breen | Complete | COMPLETE |  | Migration | MHHS-DEL770 | T3-MI-0010 | PSG | T3 |
| 2271 | 1.8.8.2 | **Migration Design** |  | 100d | 2022-11-14 A | 2023-03-31 A |  | 100% |  | 2022-11-14 | 2023-03-31 | 100d | 2022-11-14 | 2023-03-31 |  |  |  | N/A | N/A | Migration | 5.0 | N/A |  |  |  | Migration |  |  |  |  |
| 2272 | 1.8.8.2.1 | Review and update existing design artefacts and socialise with participants ahead of MDSG |  | 10d | 2022-11-14 A | 2022-11-25 A |  | 100% |  | 2022-11-14 | 2022-11-25 | 10d | 2022-11-14 | 2022-11-25 |  |  |  | SI Migration | SRO Design,CPT | Migration | 5.0 | John Wiggins,Matthew Breen | Complete | COMPLETE |  | Migration |  |  |  |  |
| 2273 | 1.8.8.2.2 | Develop design artefacts and supporting technical documents in line with MDSG |  | 53d | 2022-11-30 A | 2023-02-10 A | 2272FS+2d | 100% |  | 2022-11-30 | 2023-02-10 | 53d | 2022-11-30 | 2023-02-10 |  |  |  | SI Migration | PP,SRO Function,CPT | Migration | 5.0 | John Wiggins,Matthew Breen | Complete | COMPLETE |  | Migration |  |  |  |  |
| 2274 | 1.8.8.2.3 | Migration design artefacts issued for consultation | milestone | 0d | 2023-02-13 A | 2023-02-13 A | 2273FS+1d | 100% |  | 2023-02-13 | 2023-02-13 | 0d | 2023-02-13 | 2023-02-13 |  |  |  | SI Migration | PP,SRO Function,CPT | Migration | 5.0 | John Wiggins,Matthew Breen | Complete | COMPLETE |  | Migration |  | T3-MI-0011 | DAG | T3 |
| 2275 | 1.8.8.2.4 | Industry consultation |  | 5d | 2023-02-14 A | 2023-02-20 A | 2274SS | 100% |  | 2023-02-14 | 2023-02-20 | 5d | 2023-02-14 | 2023-02-20 |  |  |  | PP | SI Migration | Migration | 5.0 | John Wiggins,Matthew Breen | Complete | COMPLETE |  | Migration |  |  |  |  |
| 2276 | 1.8.8.2.5 | Review consultation feedback, address comments and update artefacts |  | 5d | 2023-02-21 A | 2023-02-27 A | 2275 | 100% |  | 2023-02-21 | 2023-02-27 | 5d | 2023-02-21 | 2023-02-27 |  |  |  | SI Migration | PP | Migration | 5.0 | John Wiggins,Matthew Breen | Complete | COMPLETE |  | Migration |  |  |  |  |
| 2277 | 1.8.8.2.6 | Internal artefact review and comms preparation |  | 3d | 2023-02-28 A | 2023-03-02 A | 2276 | 100% |  | 2023-02-28 | 2023-03-02 | 3d | 2023-02-28 | 2023-03-02 |  |  |  | SI Migration | SRO Function | Migration | 5.0 | John Wiggins,Matthew Breen | Complete | COMPLETE |  | Migration |  |  |  |  |
| 2278 | 1.8.8.2.7 | Updated Migration Design artefacts issued to PPs for assurance review | milestone | 0d | 2023-03-03 A | 2023-03-03 A | 2277FS+1d | 100% |  | 2023-03-03 | 2023-03-03 | 0d | 2023-03-03 | 2023-03-03 |  |  |  | SI Migration | PP | Migration | 5.0 | John Wiggins,Matthew Breen | Complete | COMPLETE |  | Migration |  | T3-MI-0013 | DAG | T3 |
| 2279 | 1.8.8.2.8 | Final Migration Design artefacts walkthrough with PPs | milestone | 0d | 2023-03-22 A | 2023-03-22 A | 2278FS+13d | 100% |  | 2023-03-22 | 2023-03-22 | 0d | 2023-03-22 | 2023-03-22 |  |  |  | SI Migration | PP | Migration | 5.0 | John Wiggins,Matthew Breen | Complete | COMPLETE |  | Migration |  |  |  |  |
| 2280 | 1.8.8.2.9 | Migration Design approved | milestone | 0d | 2023-03-31 A | 2023-03-31 A | 2279FS+7d | 100% |  | 2023-03-31 | 2023-03-31 | 0d | 2023-03-31 | 2023-03-31 |  |  |  | SI Migration | PP,SRO Function,CPT | Migration | 5.0 | John Wiggins,Matthew Breen | Complete | COMPLETE |  | Migration |  | T2-MI-0050 | DAG | T2 |

| ID | WBS | Task | Type | Duration | Start | Finish | Predecessors | Complete | Baseline start | Baseline finish | Baseline duration | Baseline 1 start | Baseline 1 finish | Baseline cost | Responsible | Involved | Text9 | Update Version | MHHS Resource Name | MHHS Programme Phase | Sched Status | RAG | Milestone ID | Text29 | Tier | Guidance |
| --- | --- | --- | --- | --- | --- | --- | --- | --- | --- | --- | --- | --- | --- | --- | --- | --- | --- | --- | --- | --- | --- | --- | --- | --- | --- | --- |
| 2281 | 1.8.8.3 | **Transition Design** |  | 186d | 2023-03-01 A | 2023-11-15 A |  | 100% | 2023-03-01 | 2023-11-15 | 186d | 2023-03-01 | 2023-08-03 | -0 | N/A | N/A | Migration | 5.0 | N/A | Migration |  |  |  |  |  |  |
| 2282 | 1.8.8.3.1 | **Tranche 1** |  | 56d | 2023-03-01 A | 2023-05-17 A |  | 100% | 2023-03-01 | 2023-05-17 | 56d | 2023-03-01 | 2023-05-17 |  | N/A | N/A | Migration | 5.0 | N/A | Migration |  |  |  |  |  |  |
| 2283 | 1.8.8.3.1.1 | Develop design artefacts and supporting technical details with participants |  | 50d | 2023-03-01 A | 2023-05-09 A |  | 100% | 2023-03-01 | 2023-05-09 | 50d | 2023-03-01 | 2023-05-09 |  | SI Design | PP | Migration | 5.0 | Andrew Margan | Migration | Complete | COMPLETE |  |  |  |  |
| 2284 | 1.8.8.3.1.2 | Issue Material for DAG approval |  | 1d | 2023-05-10 A | 2023-05-10 A | 2283 | 100% | 2023-05-10 | 2023-05-10 | 1d | 2023-05-10 | 2023-05-10 |  | PP | SI Design | Migration | 5.0 | Andrew Margan | Migration | Complete | COMPLETE |  |  |  |  |
| 2285 | 1.8.8.3.1.3 | Tranche 1 Transition Design approved | milestone | 0d | 2023-05-17 A | 2023-05-17 A | 2284FS+5d | 100% | 2023-05-17 | 2023-05-17 | 0d | 2023-05-17 | 2023-05-17 |  | SI Design | PP | Migration | 5.0 | Andrew Margan | Migration | Complete | COMPLETE | T2-DB-0150 | DAG | T2 |  |
| 2286 | 1.8.8.3.2 | **Tranche 2** |  | 130d | 2023-05-18 A | 2023-11-15 A |  | 100% | 2023-05-18 | 2023-11-15 | 130d | 2023-05-18 | 2023-08-03 | -0 | N/A | N/A | Migration | 5.0 | N/A | Migration |  |  |  |  |  |  |
| 2287 | 1.8.8.3.2.1 | Develop Initial design artefacts and supporting technical details |  | 76d | 2023-05-18 A | 2023-08-31 A | 2285 | 100% | 2023-05-18 | 2023-08-31 | 76d | 2023-05-18 | 2023-07-26 |  | SRO | PP, CPT, SRO Design | Migration | 5.5 | Andrew Margan | Migration | Complete | COMPLETE |  |  |  |  |
| 2288 | 1.8.8.3.2.2 | Communicate Initial Design Artefacts with Industry (MTDSG) |  | 1d | 2023-09-01 A | 2023-09-01 A | 2287 | 100% | 2023-09-01 | 2023-09-01 | 1d |  |  |  | SRO | PP, CPT, SRO Design | Migration | 5.5 | Andrew Margan | Migration | Complete | COMPLETE |  |  |  |  |
| 2289 | 1.8.8.3.2.3 | Host MTDSG |  | 1d | 2023-09-11 A | 2023-09-11 A | 2288FS+5d | 100% | 2023-09-11 | 2023-09-11 | 1d |  |  |  | SRO | PP, CPT, SRO Design | Migration | 5.5 | Andrew Margan | Migration | Complete | COMPLETE |  |  |  |  |
| 2290 | 1.8.8.3.2.4 | Process MTDSG Feedback and Amend Design Artefacts |  | 4d | 2023-09-12 A | 2023-09-15 A | 2289 | 100% | 2023-09-12 | 2023-09-15 | 4d |  |  |  | SRO | PP, CPT, SRO Design | Migration | 5.5 | Andrew Margan | Migration | Complete | COMPLETE |  |  |  |  |
| 2291 | 1.8.8.3.2.5 | Communicate Amended Design Artefacts with Industry |  | 1d | 2023-09-15 A | 2023-09-15 A | 2290FF | 100% | 2023-09-15 | 2023-09-15 | 1d |  |  |  | SRO | PP, CPT, SRO Design | Migration | 5.5 | Andrew Margan | Migration | Complete | COMPLETE |  |  |  |  |
| 2292 | 1.8.8.3.2.6 | Host MTDSG |  | 1d | 2023-09-26 A | 2023-09-26 A | 2291FS+6d | 100% | 2023-09-26 | 2023-09-26 | 1d |  |  |  | SRO | PP, CPT, SRO Design | Migration | 5.5 | Andrew Margan | Migration | Complete | COMPLETE |  |  |  |  |
| 2293 | 1.8.8.3.2.7 | Make Final Amendments to Design Artefact |  | 5d | 2023-09-27 A | 2023-10-03 A | 2292 | 100% | 2023-09-27 | 2023-10-03 | 5d |  |  |  | SRO | PP, CPT, SRO Design | Migration | 5.5 | Andrew Margan | Migration | Complete | COMPLETE |  |  |  |  |
| 2294 | 1.8.8.3.2.8 | Request DAG Consultation |  | 1d | 2023-10-04 A | 2023-10-04 A | 2293 | 100% | 2023-10-04 | 2023-10-04 | 1d |  |  |  | SRO | PP, CPT, SRO Design | Migration | 5.5 | Andrew Margan | Migration | Complete | COMPLETE |  |  |  |  |
| 2295 | 1.8.8.3.2.9 | Consultation Period |  | 11d | 2023-10-04 A | 2023-10-18 A | 2294SS | 100% | 2023-10-04 | 2023-10-18 | 11d |  |  |  | SRO | PP, CPT, SRO Design | Migration | 5.5 | Andrew Margan | Migration | Complete | COMPLETE |  |  |  |  |
| 2296 | 1.8.8.3.2.10 | Action Consultation Comments |  | 5d | 2023-10-19 A | 2023-10-25 A | 2295 | 100% | 2023-10-19 | 2023-10-25 | 5d |  |  |  | SRO | PP, CPT, SRO Design | Migration | 5.5 | Andrew Margan | Migration | Complete | COMPLETE |  |  |  |  |
| 2297 | 1.8.8.3.2.11 | Post Consultation Industry Assurance |  | 5d | 2023-10-26 A | 2023-11-01 A | 2296 | 100% | 2023-10-26 | 2023-11-01 | 5d |  |  |  | SRO | PP, CPT, SRO Design | Migration | 5.5 | Andrew Margan | Migration | Complete | COMPLETE |  |  |  |  |
| 2298 | 1.8.8.3.2.12 | Request DAG Approval |  | 1d | 2023-11-01 A | 2023-11-01 A | 2297FF | 100% | 2023-11-01 | 2023-11-01 | 1d |  |  |  | SRO | PP, CPT, SRO Design | Migration | 5.5 | Andrew Margan | Migration | Complete | COMPLETE |  |  |  |  |
| 2299 | 1.8.8.3.2.13 | DAG Transition Design Approved |  | 1d | 2023-11-08 A | 2023-11-08 A | 2298FS+4d | 100% | 2023-11-08 | 2023-11-08 | 1d |  |  |  | SRO | PP, CPT, SRO Design | Migration | 5.5 | Andrew Margan | Migration | Complete | COMPLETE |  |  |  |  |
| 2300 | 1.8.8.3.2.14 | Update Transition Design Admin |  | 5d | 2023-11-09 A | 2023-11-15 A | 2299 | 100% | 2023-11-09 | 2023-11-15 | 5d |  |  |  | SRO | PP, CPT, SRO Design | Migration | 5.5 | Andrew Margan | Migration | Complete | COMPLETE |  |  |  |  |
| 2301 | 1.8.8.3.2.15 | Tranche 2 Transition Design Baselined | milestone | 0d | 2023-11-15 A | 2023-11-15 A | 2300 | 100% | 2023-11-15 | 2023-11-15 | 0d | 2023-08-03 | 2023-08-03 |  | SRO | PP, CPT, SRO Design | Migration | 5.12 | Andrew Margan | Migration | Complete | COMPLETE | T2-DB-0250 | DAG | T2 | 14/8 - Date aligns with DAG |
| 2302 | 1.8.8.4 | **Data Assessment Report** |  | 61d | 2022-12-06 A | 2023-02-28 A |  | 100% | 2022-12-06 | 2023-02-28 | 61d | 2022-12-06 | 2023-02-28 |  | N/A | N/A | Migration | 5.0 | N/A | Migration |  |  |  |  |  |  |
| 2303 | 1.8.8.4.1 | Develop document with MWG |  | 49d | 2022-12-06 A | 2023-02-10 A |  | 100% | 2022-12-06 | 2023-02-10 | 49d | 2022-12-06 | 2023-02-10 |  | SI Migration |  | Migration | 5.0 | John Wiggins,Matthew Breen | Migration | Complete | COMPLETE |  |  |  |  |
| 2304 | 1.8.8.4.2 | Artefact review (via TMAG) and updates |  | 25d | 2023-01-18 A | 2023-02-21 A | 2303FS-18d | 100% | 2023-01-18 | 2023-02-21 | 25d | 2023-01-18 | 2023-02-21 |  | PP | IPA,SI Migration | Migration | 5.0 | John Wiggins,Matthew Breen | Migration | Complete | COMPLETE |  |  |  |  |
| 2305 | 1.8.8.4.3 | Data Assessment Report approved | milestone | 0d | 2023-02-28 A | 2023-02-28 A | 2304FS+5d | 100% | 2023-02-28 | 2023-02-28 | 0d | 2023-02-28 | 2023-02-28 |  | SI Migration | PP,IPA | Migration | 5.0 | John Wiggins,Matthew Breen | Migration | Complete | COMPLETE | T3-MI-0012 | MCAG | T3 |  |

Notes:
- 2301: Action: 2/8/23 - needs to be replanned to 15//11/23. AM to raise CR as T2 milestone

| ID | WBS | Task | Type | Duration | Start | Finish | Predecessors | Complete | Remaining | Baseline start | Baseline finish | Baseline duration | Baseline 1 start | Baseline 1 finish | Total slack | Free slack | Constraint | Baseline cost | Responsible | Involved | Text9 | Update Version | MHHS Resource Name | MHHS Programme Phase | Sched Status | RAG | Milestone ID | Text29 | Tier | Task Status | Guidance |
| --- | --- | --- | --- | --- | --- | --- | --- | --- | --- | --- | --- | --- | --- | --- | --- | --- | --- | --- | --- | --- | --- | --- | --- | --- | --- | --- | --- | --- | --- | --- | --- |
| 2306 | 1.8.8.5 | **Migration, Cutover & Data Strategy (incl. Migration Entry Criteria)** |  | 102d | 2022-12-08 A | 2023-04-28 A |  | 100% |  | 2022-12-08 | 2023-04-28 | 102d | 2022-12-08 | 2023-04-28 |  |  |  |  | N/A | N/A | Migration | 5.0 | N/A | Migration |  |  |  |  |  |  |  |
| 2307 | 1.8.8.5.1 | Develop document with MWG |  | 67d | 2022-12-08 A | 2023-03-10 A | 2270 | 100% |  | 2022-12-08 | 2023-03-10 | 67d | 2022-12-08 | 2023-03-10 |  |  |  |  | SI Migration | PP | Migration | 5.0 | John Wiggins,Matthew Breen | Migration | Complete | COMPLETE |  |  |  |  |  |
| 2308 | 1.8.8.5.2 | Artefact review (via TMAG) and updates |  | 28d | 2023-03-15 A | 2023-04-21 A | 2307FS+2d | 100% |  | 2023-03-15 | 2023-04-21 | 28d | 2023-03-15 | 2023-04-21 |  |  |  |  | PP | SI Migration | Migration | 5.0 | John Wiggins,Matthew Breen | Migration | Complete | COMPLETE |  |  |  |  |  |
| 2309 | 1.8.8.5.3 | Migration, Cutover & Data Strategy approved | milestone | 0d | 2023-04-28 A | 2023-04-28 A | 2308FF+5d | 100% |  | 2023-04-28 | 2023-04-28 | 0d | 2023-04-28 | 2023-04-28 |  |  |  |  | SI Migration | PP | Migration | 5.0 | John Wiggins,Matthew Breen | Migration | Complete | COMPLETE | T3-MI-0014 | MCAG | T3 |  |  |
| 2310 | 1.8.8.6 | **Data Cleanse Plan** |  | 685d | 2023-03-02 A | 2025-10-15 |  | 65% | 237.07d | 2023-03-02 | 2025-09-03 | 547d | 2023-03-02 | 2025-04-04 | 571d |  |  | -0 | N/A | N/A | Migration | 5.0 | N/A | Migration |  |  |  |  |  |  |  |
| 2311 | 1.8.8.6.1 | Develop document with MWG |  | 50d | 2023-03-02 A | 2023-05-10 A |  | 100% |  | 2023-03-02 | 2023-05-10 | 50d | 2023-03-02 | 2023-05-10 |  |  |  |  | SI Migration | PP | Migration | 5.0 | John Wiggins,Matthew Breen | Migration | Complete | COMPLETE |  |  |  |  |  |
| 2312 | 1.8.8.6.2 | Artefact review (via TMAG) and updates |  | 20d | 2023-05-11 A | 2023-06-07 A | 2311 | 100% |  | 2023-05-11 | 2023-06-07 | 20d | 2023-05-11 | 2023-06-07 |  |  |  |  | PP | SI Migration,IPA | Migration | 5.0 | John Wiggins,Matthew Breen | Migration | Complete | COMPLETE |  |  |  |  |  |
| 2313 | 1.8.8.6.3 | Data Cleanse Plan approved | milestone | 0d | 2023-07-19 A | 2023-07-19 A | 2312FS+30d | 100% |  | 2023-07-19 | 2023-07-19 | 0d | 2023-06-14 | 2023-06-14 |  |  |  |  | SI Migration | PP | Migration | 5.0 | John Wiggins,Matthew Breen | Migration | Complete | COMPLETE | T3-MI-0020 | MCAG | T3 |  |  |
| 2314 | 1.8.8.6.4 | Monitor Programme Participant adherence to Data Cleanse Plan |  | 467d | 2023-06-15 A | 2025-03-28 | 2313 | 64% | 167d | 2023-06-15 | 2025-03-28 | 467d | 2023-06-15 | 2025-03-28 | 714d |  |  |  | SI Migration | PP | Migration | 5.0 | Matthew Breen | Migration | Green | GREEN |  |  |  |  |  |
| 2315 | 1.8.8.6.5 | **MTDs** |  | 120d | 2024-08-16 A | 2025-01-31 |  | 45% | 66d | 2024-08-16 | 2025-01-31 | 91d |  |  | 754d |  |  | -0 | N/A | N/A | Transition | 5.4 | N/A | Migration |  |  |  |  |  |  |  |
| 2316 | 1.8.8.6.5.1 | **ESME ID** |  | 90d | 2024-08-16 A | 2024-12-20 |  |  | 90d | 2024-08-16 | 2024-12-20 | 90d |  |  | 784d |  |  | -0 | N/A | N/A | Transition | 5.4 | N/A | Migration |  |  |  |  |  |  |  |
| 2317 | 1.8.8.6.5.1.1 | DCC to extract ESME ID and share with LDSO | milestone | 0d | 2024-08-16 A | 2024-08-16 A | 2313FS+282d | 100% |  | 2024-08-16 | 2024-08-16 | 0d |  |  |  |  |  |  | DCC/SI |  | Transition | 5.5 | Matthew Breen | Migration | Complete | COMPLETE | T3-MI-0024 | MCAG (Transition) | T3 |  |  |
| 2318 | 1.8.8.6.5.1.2 | LDSO ‘full refresh’ between their Registration Service and the EES (ESME ID) |  | 16d | 2024-10-21 | 2024-11-11 | 2317FS+45d |  |  | 2024-10-21 | 2024-11-11 | 0d |  |  | 784d | 0d |  |  | LDSO/EES |  | Transition | 5.5 | Matthew Breen | Migration | Overdue Start | GREEN | T3-MI-0025 | MCAG (Transition) | T3 | -9.67 |  |
| 2319 | 1.8.8.6.5.1.3 | Suppliers complete investigation of exceptions and resolution of exceptions |  | 1d | 2024-12-20 | 2024-12-20 | 2318FS+28d |  |  | 2024-12-20 | 2024-12-20 | 1d |  |  | 784d | 0d |  |  | Supplier |  | Transition | 5.4 | Matthew Breen | Migration | Green | GREEN |  |  |  | 50.33 |  |
| 2320 | 1.8.8.6.5.1.4 | ESME ID Complete | milestone | 0d | 2024-12-20 | 2024-12-20 | 2319 |  |  | 2024-12-20 | 2024-12-20 | 0d |  |  | 784d |  |  |  |  |  | Transition | 5.4 | Matthew Breen | Migration | Green | GREEN |  |  |  | 50.71 |  |
| 2321 | 1.8.8.6.5.2 | **Meter Location and Number of Displayed Register Digits** |  | 101d | 2024-09-13 A | 2025-01-31 |  | 78% | 21.96d | 2024-09-13 | 2025-01-31 | 91d |  |  | 754d |  |  |  | N/A | N/A | Transition | 5.4 | N/A | Migration |  |  |  |  |  |  |  |
| 2322 | 1.8.8.6.5.2.1 | MEM to extract data and share with LDSO |  | 6d | 2024-09-13 A | 2024-09-20 A | 2313FS+301d | 100% |  | 2024-09-13 | 2024-09-20 | 1d |  |  |  |  |  |  | MEM/SI |  | Transition | 5.4 | Matthew Breen | Migration | Complete | COMPLETE |  |  |  |  |  |
| 2323 | 1.8.8.6.5.2.2 | LDSO ‘full refresh’ between their Registration Service and the EES (Meter Location and Number of Displayed Register Digits) |  | 16d | 2024-10-28 A | 2024-11-18 | 2322FS+25d | 75% | 4d | 2024-10-28 | 2024-11-18 | 0d |  |  | 754d | 0d |  |  | LDSO /EES |  | Transition | 5.5 | Matthew Breen | Migration | Green | GREEN | T3-MI-0026 | MCAG (Transition) | T3 |  |  |
| 2324 | 1.8.8.6.5.2.3 | Suppliers complete investigation of exceptions and resolution of exceptions |  | 1d | 2025-01-31 | 2025-01-31 | 2323FS+53d |  |  | 2025-01-31 | 2025-01-31 | 1d |  |  | 754d | 0d |  |  | Supplier |  | Transition | 5.4 | Matthew Breen | Migration | Green | GREEN |  |  |  | 92.33 |  |
| 2325 | 1.8.8.6.5.2.4 | Meter Location and Number of Displayed Register Digits Complete | milestone | 0d | 2025-01-31 | 2025-01-31 | 2324 |  |  | 2025-01-31 | 2025-01-31 | 0d |  |  | 754d |  |  |  |  |  | Transition | 5.4 | Matthew Breen | Migration | Green | GREEN |  |  |  | 92.71 |  |
| 2326 | 1.8.8.6.6 | **Registration Data** |  | 289d | 2024-09-06 A | 2025-10-15 |  | 10% | 261.48d | 2024-09-06 | 2025-09-03 | 147d |  |  | 571d |  |  |  | N/A | N/A | Transition | 5.4 | N/A | Migration |  |  |  |  |  |  |  |
| 2327 | 1.8.8.6.6.1 | **Connection Type** |  | 47d | 2024-09-06 A | 2024-11-11 |  | 12% | 41.47d | 2024-09-06 | 2024-11-11 | 16d |  |  | 813d |  |  |  | N/A | N/A | Transition | 5.4 | N/A | Migration |  |  |  |  |  |  |  |
| 2328 | 1.8.8.6.6.1.1 | Automated Population of Connection Type for Measurement Classes ‘B’, ‘D’, ‘F’ & ‘G’ | milestone | 0d | 2024-10-04 A | 2024-10-04 A | 2313FS+317d | 100% |  | 2024-10-04 | 2024-10-04 | 0d |  |  |  |  | start no earlier than 2024-09-13 |  | LDSO |  | Transition | 5.5 | Matthew Breen | Migration | Complete | COMPLETE | T3-MI-0027 | MCAG (Transition) | T3 |  |  |
| 2329 | 1.8.8.6.6.1.2 | BAU Population of Connection Type for Site Specific LLFCs within Measurement Classes ‘C’ & ‘E’ | milestone | 0d | 2024-10-04 A | 2024-10-04 A | 2313FS+317d | 100% |  | 2024-10-04 | 2024-10-04 | 0d |  |  |  |  |  |  | LDSO |  | Transition | 5.5 | Matthew Breen | Migration | Complete | COMPLETE | T3-MI-0028 | MCAG (Transition) | T3 |  |  |
| 2330 | 1.8.8.6.6.1.3 | Automated Population of Connection Type for Smart Meters within Measurement Class ‘A’ | milestone | 0d | 2024-10-04 A | 2024-10-04 A | 2313FS+317d | 100% |  | 2024-10-04 | 2024-10-04 | 0d |  |  |  |  |  |  | LDSO |  | Transition | 5.5 | Matthew Breen | Migration | Complete | COMPLETE | T3-MI-0029 | MCAG (Transition) | T3 |  |  |
| 2331 | 1.8.8.6.6.1.4 | Population of Connection Type for Traditional and Advanced Meters within Measurement Class ‘A’ |  | 1d | 2024-09-06 A | 2024-09-06 A | 2313FS+296d | 100% |  | 2024-09-06 | 2024-09-06 | 1d |  |  |  |  |  |  | Suppliers |  | Transition | 5.4 | Matthew Breen | Migration | Complete | COMPLETE |  |  |  |  |  |
| 2332 | 1.8.8.6.6.1.5 | Automated Population of Null Connection Type | milestone | 0d | 2024-10-04 A | 2024-10-04 A | 2313FS+317d | 100% |  | 2024-10-04 | 2024-10-04 | 0d |  |  |  |  |  |  | LDSO |  | Transition | 5.5 | Matthew Breen | Migration | Complete | COMPLETE | T3-MI-0030 | MCAG (Transition) | T3 |  |  |
| 2333 | 1.8.8.6.6.1.6 | Full MPAN refresh to ESS |  | 16d | 2024-10-21 A | 2024-11-11 | 2313FS+327d | 6% | 15d | 2024-10-21 | 2024-11-11 | 1d |  |  | 813d | 0d |  |  | LDSO/EES |  | Transition | 5.4 | Matthew Breen | Migration | Green | GREEN |  |  |  |  | Actually takes place on 29/9/24 which is a Sunday |
| 2334 | 1.8.8.6.6.1.7 | Connection Type Complete | milestone | 0d | 2024-11-11 | 2024-11-11 | 2328, 2329, 2330, 2331, 2332, 2333 |  |  | 2024-11-11 | 2024-11-11 | 0d |  |  | 813d |  |  |  |  |  | Transition | 5.4 | Matthew Breen | Migration | Green | GREEN |  |  |  | 11.71 |  |

Notes:
- 2320: Action: 2/8/24: is date right as different to baseline? Why was it 23rd?

| ID | WBS | Task | Type | Duration | Start | Finish | Predecessors | Complete | Remaining | Baseline start | Baseline finish | Baseline duration | Baseline 1 start | Baseline 1 finish | Total slack | Free slack | Constraint | Baseline cost | Responsible | Involved | Text9 | Update Version | MHHS Resource Name | MHHS Programme Phase | Guidance | Task Status | Sched Status | RAG | Milestone ID | Text29 | Tier |
| --- | --- | --- | --- | --- | --- | --- | --- | --- | --- | --- | --- | --- | --- | --- | --- | --- | --- | --- | --- | --- | --- | --- | --- | --- | --- | --- | --- | --- | --- | --- | --- |
| 2335 | 1.8.8.6.6.2 | **Domestic Premises Indicator** |  | 19d | 2025-09-19 | 2025-10-15 |  |  |  | 2025-08-08 | 2025-09-03 | 17d |  |  | 571d |  |  |  | N/A | N/A | Transition | 5.4 | N/A | Migration |  |  |  |  |  |  |  |
| 2336 | 1.8.8.6.6.2.1 | The DCC to extract Domestic Premises Indicator from the CSS and provide a file to each LDSO and EES. |  | 2d | 2025-09-19 | 2025-09-22 | 1588FS-4d |  |  | 2025-09-19 | 2025-09-22 | 1d |  |  | 571d | 0d | start no earlier than 2025-08-08 |  | DCC |  | Transition | 5.4 | Matthew Breen | Migration | 27/7 - needs to end on date of M10 7/3/25 | 323.33 | Green | GREEN |  |  |  |
| 2337 | 1.8.8.6.6.2.2 | Each LDSO notifies the DCC of any exceptions |  | 1d | 2025-09-23 | 2025-09-23 | 2336 |  |  | 2025-09-23 | 2025-09-23 | 1d |  |  | 571d | 0d |  |  | LDSO |  | Transition | 5.4 | Matthew Breen | Migration | 27/7 - needs to end on date of M10 7/3/25 | 327.33 | Green | GREEN |  |  |  |
| 2338 | 1.8.8.6.6.2.3 | Each LDSO and DCC completes investigation and resolution of exceptions |  | 1d | 2025-10-15 | 2025-10-15 | 2336FS+15d, 2337FS+15d |  |  | 2025-10-15 | 2025-10-15 | 1d |  |  | 571d | 0d |  |  | LDSO / DCC |  | Transition | 5.4 | Matthew Breen | Migration | 27/7 Needs to take place approx. 1 month after M10 | 349.33 | Green | GREEN |  |  |  |
| 2339 | 1.8.8.6.6.2.4 | Domestic Premises Indicator Complete | milestone | 0d | 2025-10-15 | 2025-10-15 | 2338 |  |  | 2025-10-15 | 2025-10-15 | 0d |  |  | 571d |  |  |  |  |  | Transition | 5.4 | Matthew Breen | Migration |  | 349.71 | Green | GREEN |  |  |  |
| 2340 | 1.8.8.6.7 | **Export / Import MPANs** |  | 151d | 2024-03-22 A | 2024-10-18 A |  | 100% |  | 2024-03-22 | 2024-10-18 | 151d |  |  |  |  |  |  | N/A | N/A | Transition | 5.4 | N/A | Migration |  |  |  |  |  |  |  |
| 2341 | 1.8.8.6.7.1 | **Linking of Export / Import MPANS** |  | 151d | 2024-03-22 A | 2024-10-18 A |  | 100% |  | 2024-03-22 | 2024-10-18 | 151d |  |  |  |  |  |  | N/A | N/A | Transition | 5.4 | N/A | Migration |  |  |  |  |  |  |  |
| 2342 | 1.8.8.6.7.1.1 | LDSO utilises BAU processing (DB05s) to populate each import/export association |  | 1d | 2024-03-22 A | 2024-03-22 A | 2313FS+176d | 100% |  | 2024-03-22 | 2024-03-22 | 1d |  |  |  |  |  |  | LDSO |  | Transition | 5.4 | Matthew Breen | Migration |  |  | Complete | COMPLETE |  |  |  |
| 2343 | 1.8.8.6.7.1.2 | Each LDSO notifies the Registered Supplier of any exceptions |  | 1d | 2024-04-19 A | 2024-04-19 A | 2342FS+19d | 100% |  | 2024-04-19 | 2024-04-19 | 1d |  |  |  |  |  |  | LDSO |  | Transition | 5.4 | Matthew Breen | Migration |  |  | Complete | COMPLETE |  |  |  |
| 2344 | 1.8.8.6.7.1.3 | Each Supplier completes investigation and resolution of exceptions |  | 1d | 2024-08-23 A | 2024-08-23 A | 2343FS+89d | 100% |  | 2024-08-23 | 2024-08-23 | 1d |  |  |  |  |  |  | Supplier |  | Transition | 5.4 | Matthew Breen | Migration |  |  | Complete | COMPLETE |  |  |  |
| 2345 | 1.8.8.6.7.1.4 | Each LDSO has linked al relevant import/export MPANS | milestone | 0d | 2024-10-18 A | 2024-10-18 A | 2344FS+40d | 100% |  | 2024-10-18 | 2024-10-18 | 0d |  |  |  |  |  |  | LDSO |  | Transition | 5.5 | Matthew Breen | Migration |  |  | Complete | COMPLETE | T3-MI-0031 | MCAG (Transition) | T3 |
| 2346 | 1.8.8.6.7.1.5 | Linking of Export / Import MPANS Complete | milestone | 0d | 2024-10-18 A | 2024-10-18 A | 2345 | 100% |  | 2024-10-18 | 2024-10-18 | 0d |  |  |  |  |  |  |  |  | Transition | 5.4 | Matthew Breen | Migration |  |  | Complete | COMPLETE |  |  |  |
| 2347 | 1.8.8.6.8 | Pre-migration data cleanse complete | milestone | 0d | 2025-08-13 | 2025-08-13 |  |  |  | 2025-08-13 | 2025-08-13 | 0d | 2025-04-04 | 2025-04-04 | 617d |  | start no earlier than 2025-08-13 |  | SI Migration | PP | Transition | 5.0 | Matthew Breen | Migration |  | 286.33 | Green | GREEN | T2-MI-0450 | MCAG (Transition) | T2 |
| 2348 | 1.8.9 | **Migration Period Planning** |  | 367d | 2023-07-03 A | 2024-11-26 |  | 83% | 61.71d | 2023-07-03 | 2024-11-26 | 851d | 2023-07-03 | 2026-10-05 | 678d |  |  | -0 | N/A | N/A | Transition | 5.0 | N/A | Migration |  | M10 |  |  |  |  |  |
| 2349 | 1.8.9.1 | **Migration Implementation Plan (incl. Migration Exit Criteria)** |  | 367d | 2023-07-03 A | 2024-11-26 |  | 83% | 61.71d | 2023-07-03 | 2024-11-26 | 851d | 2023-07-03 | 2026-10-05 | 678d |  |  | -0 | N/A | N/A | Transition | 5.0 | N/A | Migration |  |  |  |  |  |  |  |
| 2350 | 1.8.9.1.1 | **Migration Threshold Volumes** |  | 101d | 2023-07-03 A | 2023-11-20 A |  | 100% |  | 2023-07-03 | 2023-11-20 | 98d | 2023-07-03 | 2023-08-31 |  |  |  | -0 | N/A | N/A | Transition | 5.0 | N/A | Migration |  |  |  |  |  |  |  |
| 2351 | 1.8.9.1.1.1 | Threshold volumes reviewed by MWG |  | 54d | 2023-07-03 A | 2023-09-14 A |  | 100% |  | 2023-07-03 | 2023-09-14 | 54d | 2023-07-03 | 2023-07-28 |  |  |  |  | SI Migration | PP | Transition | 5.6 | John Wiggins,Matthew Breen | Migration |  |  | Complete | COMPLETE |  |  |  |
| 2352 | 1.8.9.1.1.2 | Artefact review (via TMAG) and updates |  | 47d | 2023-09-15 A | 2023-11-20 A | 2351 | 100% |  | 2023-09-15 | 2023-11-20 | 44d | 2023-07-31 | 2023-08-31 |  |  |  |  | PP | SI Migration | Transition | 5.9 | John Wiggins,Matthew Breen | Migration |  |  | Complete | COMPLETE |  |  |  |
| 2353 | 1.8.9.1.1.3 | Threshold volumes approved at TMAG | milestone | 0d | 2023-11-20 A | 2023-11-20 A | 2352 | 100% |  | 2023-11-20 | 2023-11-20 | 0d | 2023-08-31 | 2023-08-31 |  |  |  |  | SI Migration | PP | Transition | 5.12 | John Wiggins,Matthew Breen | Migration |  |  | Complete | COMPLETE | T3-MI-0021 | SITAG | T3 |
| 2354 | 1.8.9.1.2 | **Define acceptance criteria for M15** |  | 78d | 2023-09-04 A | 2023-12-20 A |  | 100% |  | 2023-09-04 | 2023-12-20 | 78d | 2023-09-04 | 2023-11-30 |  |  |  | -0 | N/A | N/A | Transition | 5.0 | N/A | Migration |  |  |  |  |  |  |  |
| 2355 | 1.8.9.1.2.1 | Review acceptance criteria and reporting requirements with MWG |  | 49d | 2023-09-04 A | 2023-11-09 A |  | 100% |  | 2023-09-04 | 2023-11-09 | 40d | 2023-09-04 | 2023-10-27 |  |  | start no earlier than 2023-09-04 |  | SI Migration |  | Transition | 5.0 | John Wiggins,Matthew Breen | Migration |  |  | Complete | COMPLETE |  |  |  |
| 2356 | 1.8.9.1.2.2 | Artefact review (via TMAG) and updates |  | 29d | 2023-11-10 A | 2023-12-20 A | 2355 | 100% |  | 2023-11-10 | 2023-12-20 | 29d | 2023-10-30 | 2023-11-30 |  |  | start no earlier than 2023-10-30 |  | PP | SI Migration | Transition | 5.0 | John Wiggins,Matthew Breen | Migration |  |  | Complete | COMPLETE |  |  |  |
| 2357 | 1.8.9.1.2.3 | Acceptance criteria for M15 agreed at TMAG | milestone | 0d | 2023-12-20 A | 2023-12-20 A | 2356 | 100% |  | 2023-12-20 | 2023-12-20 | 0d | 2023-11-30 | 2023-11-30 |  |  | finish no earlier than 2023-11-30 |  | SI Migration |  | Transition | 5.14 | John Wiggins,Matthew Breen | Migration |  |  | Complete | COMPLETE | T3-MI-0022 | SITAG | T3 |
| 2358 | 1.8.9.1.3 | **M10/M11 cut-over plan** |  | 119d | 2023-12-21 A | 2024-06-04 A |  | 100% |  | 2023-12-21 | 2024-06-04 | 119d | 2024-01-01 | 2024-05-31 |  |  |  | -0 | N/A | N/A | Transition | 5.16 | N/A | Migration |  |  |  |  |  |  |  |
| 2359 | 1.8.9.1.3.1 | Draft Document |  | 84d | 2023-12-21 A | 2024-04-16 A | 2357 | 100% |  | 2023-12-21 | 2024-04-16 | 84d |  |  |  |  |  |  | SI Transition | SI Transition,PP,SRO | Transition | 5.16 | Matthew Breen | Migration |  |  | Complete | COMPLETE |  |  |  |
| 2360 | 1.8.9.1.3.2 | Share Document with SRO |  | 1d | 2024-04-17 A | 2024-04-17 A | 2359 | 100% |  | 2024-04-17 | 2024-04-17 | 1d |  |  |  |  |  |  | SI Transition | SI Transition,PP,SRO | Transition | 5.16 | Matthew Breen | Migration |  |  | Complete | COMPLETE |  |  |  |
| 2361 | 1.8.9.1.3.3 | Industry Consultation |  | 11d | 2024-04-23 A | 2024-05-07 A | 2360FS+3d | 100% |  | 2024-04-23 | 2024-05-07 | 11d |  |  |  |  |  |  | SI Transition | SI Transition,PP,SRO | Transition | 5.16 | Matthew Breen | Migration |  |  | Complete | COMPLETE |  |  |  |
| 2362 | 1.8.9.1.3.4 | Assurance Meeting |  | 1d | 2024-05-21 A | 2024-05-21 A | 2361FS+9d | 100% |  | 2024-05-21 | 2024-05-21 | 1d |  |  |  |  |  |  | SI Transition | SI Transition,PP,SRO | Transition | 5.16 | Matthew Breen | Migration |  |  | Complete | COMPLETE |  |  |  |
| 2363 | 1.8.9.1.3.5 | MCAG Approval of M10/M11 Cut-over Plan | milestone | 0d | 2024-06-04 A | 2024-06-04 A | 2362FS+10d | 100% |  | 2024-06-04 | 2024-06-04 | 0d | 2024-05-31 | 2024-05-31 |  |  |  |  | SI Transition | SI Transition,PP,SRO | Transition | 5.26 | Matthew Breen | Migration |  |  | Complete | COMPLETE | T3-MI-0023 | MCAG | T3 |

| ID | WBS | Task | Type | Duration | Start | Finish | Predecessors | Complete | Remaining | Baseline start | Baseline finish | Baseline duration | Baseline 1 start | Baseline 1 finish | Total slack | Free slack | Constraint | Baseline cost | Responsible | Involved | Text9 | Update Version | MHHS Resource Name | MHHS Programme Phase | Sched Status | RAG | Task Status | Milestone ID | Text29 | Tier | Action |
| --- | --- | --- | --- | --- | --- | --- | --- | --- | --- | --- | --- | --- | --- | --- | --- | --- | --- | --- | --- | --- | --- | --- | --- | --- | --- | --- | --- | --- | --- | --- | --- |
| 2364 | 1.8.9.1.4 | **M16 Methodology** |  | 85d | 2024-07-31 A | 2024-11-26 |  | 10% | 76.9d | 2024-07-31 | 2024-11-26 | 85d | 2023-10-02 | 2024-04-26 | 678d |  |  | -0 | N/A | N/A | Transition | 5.0 | N/A | Migration |  |  |  |  |  |  |  |
| 2365 | 1.8.9.1.4.1 | Draft Document |  | 50d | 2024-07-31 A | 2024-10-08 |  | 12% | 44d | 2024-07-31 | 2024-10-08 | 50d | 2023-10-02 | 2023-12-29 | 678d | 0d |  |  | SI Transition | SI Transition,PP,SRO | Transition | 5.26 | Matthew Breen | Migration | Overdue | RED |  |  |  |  |  |
| 2366 | 1.8.9.1.4.2 | Share Document with SRO |  | 1d | 2024-10-09 | 2024-10-09 | 2365 |  |  | 2024-10-09 | 2024-10-09 | 1d | 2024-01-01 | 2024-01-26 | 678d | 0d |  |  | SI Transition | SI Transition,PP,SRO | Transition | 5.26 | Matthew Breen | Migration | Overdue Start | RED | -21.67 |  |  |  |  |
| 2367 | 1.8.9.1.4.3 | Industry Consultation |  | 11d | 2024-10-15 | 2024-10-29 | 2366FS+3d |  |  | 2024-10-15 | 2024-10-29 | 11d | 2024-01-29 | 2024-03-29 | 678d | 0d |  |  | SI Transition | SI Transition,PP,SRO | Transition | 5.26 | Matthew Breen | Migration | Overdue Start | RED | -15.67 |  |  |  |  |
| 2368 | 1.8.9.1.4.4 | Assurance Meeting |  | 1d | 2024-11-12 | 2024-11-12 | 2367FS+9d |  |  | 2024-11-12 | 2024-11-12 | 1d | 2024-04-01 | 2024-04-26 | 678d | 0d |  |  | SI Transition | SI Transition,PP,SRO | Transition | 5.26 | Matthew Breen | Migration | Green | RED | 12.33 |  |  |  |  |
| 2369 | 1.8.9.1.4.5 | M16 methodology approved | milestone | 0d | 2024-11-26 | 2024-11-26 | 2368FS+10d |  |  | 2024-11-26 | 2024-11-26 | 0d | 2024-04-26 | 2024-04-26 | 678d |  |  |  | SI Transition | SI Transition,PP,SRO | Transition | 5.26 | Matthew Breen | Migration | Green | RED | 26.71 | T3-MI-0500 | MCAG (Transition) | T2 |  |
| 2370 | 1.8.10 | **Preparation for Cutover to Live** |  | 341d | 2024-06-28 A | 2025-10-17 |  |  | 341d | 2024-06-28 | 2025-10-22 | 201d | 2025-02-07 | 2025-04-04 | 569d |  |  | -0 | N/A | N/A | Transition | 6.11 | N/A | Migration |  |  |  |  |  |  |  |
| 2371 | 1.8.10.1 | **Central Systems Prepare for Cutover to Live** |  | 326d | 2024-06-28 A | 2025-09-26 |  |  | 326d | 2024-06-28 | 2025-09-26 | 186d | 2025-02-07 | 2025-03-07 | 584d |  |  | -0 | N/A | N/A | Transition | 6.11 | N/A | Migration |  |  | M13 |  |  |  |  |
| 2372 | 1.8.10.1.1 | DCC (Functionality available June 2024) | milestone | 0d | 2024-06-28 A | 2024-06-28 A |  | 100% |  | 2024-06-28 | 2024-06-28 | 0d |  |  |  |  | start no earlier than 2024-06-28 |  | DCC |  | Transition | 6.11 | Matthew Breen |  | Complete | COMPLETE |  |  |  |  |  |
| 2373 | 1.8.10.1.2 | **Development of Comms Approach and Declaration Guidance** |  | 79d | 2025-04-28 | 2025-08-14 |  |  |  | 2025-03-03 | 2025-06-19 | 79d |  |  | 34d |  |  |  | N/A | N/A | Transition | 6.11 | N/A |  |  |  | 95.33 |  |  |  |  |
| 2374 | 1.8.10.1.2.1 | Draft Cutover Comms Approach |  | 59d | 2025-04-28 | 2025-07-17 |  |  |  | 2025-04-28 | 2025-07-17 | 59d |  |  | 34d | 0d | start no earlier than 2025-04-28 |  | SI Transition | SI Transition | Transition | 6.11 | Matthew Breen |  | Green | GREEN | 179.33 |  |  |  |  |
| 2375 | 1.8.10.1.2.2 | Draft Cutover Comms Approach shared | milestone | 0d | 2025-07-17 | 2025-07-17 | 2374 |  |  | 2025-07-17 | 2025-07-17 | 0d |  |  | 34d | 0d |  |  | SI Transition | SI Transition | Transition | 6.11 | Matthew Breen |  | Green | GREEN | 259.71 |  |  |  |  |
| 2376 | 1.8.10.1.2.3 | Development of Implementation Group |  | 59d | 2025-04-28 | 2025-07-17 |  |  |  | 2025-04-28 | 2025-07-17 | 59d |  |  | 34d | 0d | start no earlier than 2025-04-28 |  | SI Transition | SI Transition | Transition | 6.11 | Matthew Breen |  | Green | GREEN | 179.33 |  |  |  |  |
| 2377 | 1.8.10.1.2.4 | Implementation Group Established | milestone | 0d | 2025-07-17 | 2025-07-17 | 2376 |  |  | 2025-07-17 | 2025-07-17 | 0d |  |  | 34d | 0d |  |  | SI Transition | SI Transition | Transition | 6.11 | Matthew Breen |  | Green | GREEN | 259.71 |  |  |  |  |
| 2378 | 1.8.10.1.2.5 | Finalised Cutover Comms Approach shared | milestone | 0d | 2025-08-14 | 2025-08-14 | 2375FS+20d, 2377FS+20d |  |  | 2025-08-14 | 2025-08-14 | 0d |  |  | 34d | 29d |  |  | SI Transition | SI Transition | Transition | 6.11 | Matthew Breen |  | Green | GREEN | 287.71 |  |  |  |  |
| 2379 | 1.8.10.1.3 | **Development of Cutover Plan requirements with Participants** |  | 94d | 2025-04-28 | 2025-09-04 |  |  |  | 2025-03-03 | 2025-08-06 | 59d |  |  | 19d |  |  |  | N/A | N/A | Transition | 6.11 | N/A |  |  |  | -605.67 |  |  |  |  |
| 2380 | 1.8.10.1.3.1 | Development of SIT Participant Cutover Plans |  | 59d | 2025-04-28 | 2025-07-17 |  |  |  | 2025-04-28 | 2025-07-17 | 59d |  |  | 19d | 0d | start no earlier than 2025-04-28 |  | SI Transition | SI Transition | Transition | 6.11 | Matthew Breen |  | Green | GREEN | 179.33 |  |  |  |  |
| 2381 | 1.8.10.1.3.2 | SIT Participant Cutover Plans Ready | milestone | 0d | 2025-07-17 | 2025-07-17 | 2380 |  |  | 2025-07-17 | 2025-07-17 | 0d |  |  | 19d | 0d |  |  | SI Transition | SI Transition | Transition | 6.11 | Matthew Breen |  | Green | GREEN | 259.71 |  |  |  |  |
| 2382 | 1.8.10.1.3.3 | Programme SIT Participant Cutover Plan Assurance |  | 35d | 2025-07-18 | 2025-09-04 | 2381 |  |  | 2025-07-18 | 2025-09-17 | 44d |  |  | 19d | 14d |  |  | SI Transition | SI Transition | Transition | 6.11 | Matthew Breen |  | Green | GREEN | 260.33 |  |  |  |  |
| 2383 | 1.8.10.1.4 | **M10/M11 Cutover Activities** |  | 15d | 2025-09-05 | 2025-09-26 |  |  |  | 2025-04-14 | 2025-09-26 | 15d |  |  | 12d |  |  | -0 |  |  | Transition | 6.11 |  |  |  |  | -608.67 |  |  |  |  |
| 2384 | 1.8.10.1.4.1 | Production DIP Portal (DIP Deployment) | milestone | 0d | 2025-09-05 | 2025-09-05 | 1451FS+10d |  |  | 2025-09-05 | 2025-09-05 | 0d |  |  | 12d | 7d |  |  | Elexon,DIP Manager | Elexon,DIP Manager, SI Transition | Transition | 6.11 | Matthew Breen |  | Green | GREEN | 309.71 |  |  |  |  |
| 2385 | 1.8.10.1.4.2 | Production Certificates (DIP Deployment) | milestone | 0d | 2025-09-05 | 2025-09-05 | 1451FS+10d |  |  | 2025-09-05 | 2025-09-05 | 0d |  |  | 12d | 7d |  |  | Elexon,DIP Manager | Elexon,DIP Manager, SI Transition | Transition | 6.11 | Matthew Breen |  | Green | GREEN | 309.71 |  |  |  |  |
| 2386 | 1.8.10.1.4.3 | Completion of the pre-M10 MHHS Data Cleanse | milestone | 0d | 2025-09-24 | 2025-09-24 | 1588 |  |  | 2025-09-24 | 2025-09-24 | 0d |  |  | 586d |  |  |  | PP,DCC,SI Transition | PP,DCC,SI Transition | Transition | 6.11 | Matthew Breen |  | Green | GREEN | 328.71 |  |  |  |  |
| 2387 | 1.8.10.1.4.4 | Market-wide Participant MHHS Supporting Functionality Ready - Confirmation from Code Bodies | milestone | 0d | 2025-09-15 | 2025-09-15 | 1588FS-8d |  |  | 2025-09-15 | 2025-09-15 | 0d |  |  | 594d |  |  |  | Code Bodies | Code Bodies,SI Transition | Transition | 6.11 | Matthew Breen |  | Green | GREEN | 319.33 |  |  |  |  |
| 2388 | 1.8.10.1.4.5 | Market-wide Participant MHHS Supporting Functionality Ready | milestone | 0d | 2025-09-22 | 2025-09-22 | 1588FS-3d |  |  | 2025-09-22 | 2025-09-22 | 0d |  |  | 589d |  |  |  | PP | PP,SI Transition | Transition | 6.11 | Matthew Breen |  | Green | GREEN | 326.33 |  |  |  |  |
| 2389 | 1.8.10.1.4.6 | Elexon Central Services Deployment | milestone | 0d | 2025-09-19 | 2025-09-19 | 2411 |  |  | 2025-09-19 | 2025-09-19 | 0d |  |  | 5d | 0d |  |  | DIP Manager,Elexon | DIP Manager,Elexon,SI Transition | Transition | 6.11 | Matthew Breen |  | Green | GREEN | 323.71 |  |  |  |  |
| 2390 | 1.8.10.1.4.7 | Service Management Go-Live | milestone | 0d | 2025-09-19 | 2025-09-19 | 2411 |  |  | 2025-09-19 | 2025-09-19 | 0d |  |  | 5d | 0d |  |  | Elexon | Elexon,SI Transition | Transition | 6.11 | Matthew Breen |  | Green | GREEN | 323.71 |  |  |  |  |
| 2391 | 1.8.10.1.4.8 | Data Transfer Service (DTS) New Functionality Deployment | milestone | 0d | 2025-09-19 | 2025-09-19 | 2411 |  |  | 2025-09-19 | 2025-09-19 | 0d |  |  | 5d | 0d |  |  | Code Bodies,Electralink | Code Bodies,SI Transition | Transition | 6.11 | Matthew Breen |  | Green | GREEN | 323.71 |  |  |  |  |
| 2392 | 1.8.10.1.4.9 | Electricity Enquiry Service (EES) Deployment | milestone | 0d | 2025-09-19 | 2025-09-19 | 2411 |  |  | 2025-09-19 | 2025-09-19 | 0d |  |  | 5d | 0d |  |  | Code Bodies | Code Bodies,SI Transition | Transition | 6.11 | Matthew Breen |  | Green | GREEN | 323.71 |  |  |  |  |
| 2393 | 1.8.10.1.4.10 | MPRS, UMSO Role, LDSO Role Operational | milestone | 0d | 2025-09-19 | 2025-09-19 | 2411 |  |  | 2025-09-19 | 2025-09-19 | 0d |  |  | 5d | 0d |  |  | PP | SI Transition,PP | Transition | 6.11 | Matthew Breen |  | Green | GREEN | 323.71 |  |  |  |  |
| 2394 | 1.8.10.1.4.11 | Population of Domestic Premises Indicator | milestone | 0d | 2025-09-19 | 2025-09-19 | 2411 |  |  | 2025-09-19 | 2025-09-19 | 0d |  |  | 5d | 0d |  |  | PP,DCC,SI Transition | PP,DCC,SI Transition | Transition | 6.11 | Matthew Breen |  | Green | GREEN | 323.71 |  |  |  |  |
| 2395 | 1.8.10.1.4.12 | Population of Market Segment | milestone | 0d | 2025-09-19 | 2025-09-19 | 2411 |  |  | 2025-09-19 | 2025-09-19 | 0d |  |  | 5d | 0d |  |  | PP,SI Transition | PP,SI Transition | Transition | 6.11 | Matthew Breen |  | Green | GREEN | 323.71 |  |  |  |  |
| 2396 | 1.8.10.1.4.13 | Early Life Support Implemented | milestone | 0d | 2025-09-19 | 2025-09-19 | 2411 |  |  | 2025-09-19 | 2025-09-19 | 0d |  |  | 8d | 3d |  |  | SI Transition,Elexon,Central Services | SI Transition,Elexon,Central Services | Transition | 6.11 | Matthew Breen |  | Green | GREEN | 323.71 |  |  |  |  |
| 2397 | 1.8.10.1.4.14 | MCC Tested and Ready to Operate | milestone | 0d | 2025-09-19 | 2025-09-19 |  |  |  | 2025-09-19 | 2025-09-19 | 0d |  |  | 590d | 0d | start no earlier than 2025-09-19 |  | SI Migration | SI Migration | Transition | 6.11 | Matthew Breen |  | Green | GREEN | 323.33 |  |  |  | 1/7: To link into migration/service activation |
| 2398 | 1.8.10.1.4.15 | MCC Operational | milestone | 0d | 2025-09-19 | 2025-09-19 | 2397 |  |  | 2025-09-19 | 2025-09-19 | 0d |  |  | 590d |  |  |  | SI Migration | SI Migration | Transition | 6.11 | Matthew Breen |  | Green | GREEN | 323.33 |  |  |  | 1/7: To link into migration/service activation |
| 2399 | 1.8.4.1.4 | Central Systems live and Codes designated at 00:00 | milestone | 0d | 2025-09-22 | 2025-09-22 | 2389FS+1d, 2390FS+1d, 2391FS+1d, 2392FS+1d, 2393FS+1d, 2394FS+1d, 2395FS+1d, 2372FS+1d |  |  | 2025-09-22 | 2025-09-22 | 0d |  |  | 5d | 0d |  |  | SI Transition | SI Transition | Transition | 6.11 | Matthew Breen |  | Green | GREEN | 326.71 | T3-MI-0034 | MCAG (Transition) |  |  |
| 2400 | 1.8.10.1.4.17 | SIT Participant Qualification - The final date by which participant qualification status can be confirmed for participants to be ready for the start of Migration at M11. | milestone | 0d | 2025-09-26 | 2025-09-26 | 1451FS+25d |  |  | 2025-09-26 | 2025-09-26 | 0d |  |  | 19d | 11d |  |  | PP,Code Bodies,BSC PAB | SI Transition,PP,Code Bodies,BSC PAB | Transition | 6.11 | Matthew Breen |  | Green | GREEN | 330.71 |  |  |  |  |

Notes:
- 2369: Production of this artefact has been delayed pending discussion on outstanding artefacts to be produced through TORWG.
- 2387: 09/10/24 - WR and Fola O extended duration by 110d so the activity completes at 04/08/25.
- 2388: 09/10/24 - WR and Fola O reduced the lag so the activity completes at 11/08/25.
- 2399: Guidance: 25/7/24: New Milestone approved at MCAG on 25/7/24. It was initially approved at MCAG on 4/6 but didn't follow the usual process so addded to July MCAG for noting

| ID | WBS | Task | Type | Duration | Start | Finish | Predecessors | Baseline start | Baseline finish | Baseline duration | Total slack | Free slack | Constraint | Responsible | Involved | Text9 | Task Status | Update Version | MHHS Resource Name | Sched Status | RAG | Milestone ID | Text29 |
| --- | --- | --- | --- | --- | --- | --- | --- | --- | --- | --- | --- | --- | --- | --- | --- | --- | --- | --- | --- | --- | --- | --- | --- |
| 2401 | 1.8.10.2 | **Cutover Governance M10** |  | 11d | 2025-09-10 | 2025-09-24 |  | 2025-07-30 | 2025-09-24 | 27d | 8d |  |  | N/A | N/A | Transition | -595.67 | 6.11 | N/A |  |  |  |  |
| 2402 | 1.8.10.2.1 | Confirmation that Pre-migration Data Cleanse Activities have successfully taken place | milestone | 0d | 2025-09-10 | 2025-09-10 |  | 2025-09-10 | 2025-09-10 | 0d | 10d | 5d | start no earlier than 2025-09-10 | PP | SI Transition,PP | Transition | 314.33 | 6.11 | Matthew Breen | Green | GREEN |  |  |
| 2403 | 1.8.10.2.2 | Confirmation of Helix E2E Settlement Testing Complete | milestone | 0d | 2025-09-15 | 2025-09-15 |  | 2025-09-15 | 2025-09-15 | 0d | 7d | 2d | start no earlier than 2025-09-15 |  |  | Transition | 319.33 | 6.11 |  | Green | GREEN |  |  |
| 2404 | 1.8.10.2.3 | Confirmation of assurance of Helix E2E Settlement Testing | milestone | 0d | 2025-09-15 | 2025-09-15 |  | 2025-09-15 | 2025-09-15 | 0d | 7d | 2d | start no earlier than 2025-09-15 |  |  | Transition | 319.33 | 6.11 |  | Green | GREEN |  |  |
| 2405 | 1.8.10.2.4 | Confirmation of Qualification Status for SIT MVC | milestone | 0d | 2025-09-15 | 2025-09-15 |  | 2025-09-15 | 2025-09-15 | 0d | 7d | 2d | start no earlier than 2025-09-15 | SIT MVC,Code Bodies | SI Transition,SIT MVC,Code Bodies | Transition | 319.33 | 6.11 | Matthew Breen | Green | GREEN |  |  |
| 2406 | 1.8.10.2.5 | Confirmation of Qualification Status for Non-SIT LDSOs | milestone | 0d | 2025-09-15 | 2025-09-15 |  | 2025-09-15 | 2025-09-15 | 0d | 7d | 2d | start no earlier than 2025-09-15 | PP,Code Bodies | SI Transition,PP,Code Bodies | Transition | 319.33 | 6.11 | Matthew Breen | Green | GREEN |  |  |
| 2407 | 1.8.10.2.6 | Confirmation of Qualification Status of at least one Supplier and their contracted Agents | milestone | 0d | 2025-09-15 | 2025-09-15 |  | 2025-09-15 | 2025-09-15 | 0d | 7d | 2d | start no earlier than 2025-09-15 | S&A Qualification | SI Transition,S&A Qualification | Transition | 319.33 | 6.11 | Matthew Breen | Green | GREEN |  |  |
| 2408 | 1.8.10.2.7 | Declaration from all Central Services and LDSOs that they are in a position to move forwards | milestone | 0d | 2025-09-15 | 2025-09-15 |  | 2025-09-15 | 2025-09-15 | 0d | 8d | 3d | start no earlier than 2025-09-15 | DIP Manager,Elexon,PP,Code Bodies | SI Transition,DIP Manager,Elexon,PP,Code Bodies | Transition | 319.33 | 6.11 | Matthew Breen | Green | GREEN |  |  |
| 2409 | 1.8.10.2.8 | Market-wide Participant MHHS Migration Supporting Functionality is Live | milestone | 0d | 2025-09-15 | 2025-09-15 |  | 2025-09-15 | 2025-09-15 | 0d | 8d | 3d | start no earlier than 2025-09-15 |  |  | Transition | 319.33 | 6.11 |  | Green | GREEN |  |  |
| 2410 | 1.8.10.2.9 | TORWG (Recommendation from TORWG that the Programme should enter M10) | milestone | 0d | 2025-09-17 | 2025-09-17 | 2402FS+1d, 2405FS+1d, 2407FS+1d, 2384FS+1d, 2385FS+1d, 2493FS+1d, 2403FS+1d, 2404FS+1d, 2406FS+1d, 2408, 2409 | 2025-09-17 | 2025-09-17 | 0d | 5d | 0d |  | SI Transition | SI Transition | Transition | 321.71 | 6.11 | Matthew Breen | Green | GREEN |  |  |
| 2411 | 1.8.4.1.4 | MCAG (Confirm that the Programme can Enter M10) | milestone | 0d | 2025-09-19 | 2025-09-19 | 2410FS+2d, 2499 | 2025-09-19 | 2025-09-19 | 0d | 5d | 0d |  | SI Migration | SI Transition,SI Migration | Transition | 323.71 | 6.11 | Matthew Breen | Green | GREEN | T3-MI-0035 | MCAG (Transition) |
| 2412 | 1.8.10.2.11 | Self-Declaration from all Central Services and LDSOs that Cutover activities have been successfully carried out | milestone | 0d | 2025-09-22 | 2025-09-22 | 2411FS+1d | 2025-09-22 | 2025-09-22 | 0d | 8d | 0d |  | PP,DCC,Code Bodies | SI Transition,PP,DCC,Code Bodies | Transition | 326.71 | 6.11 | Matthew Breen | Green | GREEN |  |  |
| 2413 | 1.8.10.2.12 | Confirmation that DIP and ECS have been deployed, Service management is active, ISD has been populated | milestone | 0d | 2025-09-22 | 2025-09-22 | 2411FS+1d | 2025-09-22 | 2025-09-22 | 0d | 8d | 0d |  | Elexon,DIP Manager | SI Transition,Elexon,DIP Manager | Transition | 326.71 | 6.11 | Matthew Breen | Green | GREEN |  |  |
| 2414 | 1.8.10.2.13 | Self-Declarations against all M10 Data Cleanse Activities | milestone | 0d | 2025-09-22 | 2025-09-22 | 2411FS+1d | 2025-09-22 | 2025-09-22 | 0d | 8d | 0d |  | PP | SI Transition,PP | Transition | 326.71 | 6.11 | Matthew Breen | Green | GREEN |  |  |
| 2415 | 1.8.10.2.14 | IF-047 has been sent | milestone | 0d | 2025-09-22 | 2025-09-22 | 2411FS+1d | 2025-09-22 | 2025-09-22 | 0d | 8d | 0d |  | ECS | SI Transition,ECS | Transition | 326.71 | 6.11 | Matthew Breen | Green | GREEN |  |  |
| 2416 | 1.8.10.2.15 | Recommendation from TORWG that PSG should approve M10 | milestone | 0d | 2025-09-23 | 2025-09-23 | 2412FS+1d, 2413FS+1d, 2414FS+1d, 2415FS+1d, 2497 | 2025-09-23 | 2025-09-23 | 0d | 8d | 0d |  | SI Transition | SI Transition | Transition | 327.71 | 6.11 | Matthew Breen | Green | GREEN |  |  |
| 2417 | 1.8.10.2.16 | PSG (OFGEM and PSG to Approve That Conditions of M10 and M13 Have Been Met) | milestone | 0d | 2025-09-24 | 2025-09-24 | 2416FS+1d | 2025-09-24 | 2025-09-24 | 0d | 8d | 0d |  | SI Transition,Ofgem | SI Transition,Ofgem | Transition | 328.71 | 6.11 | Matthew Breen | Green | GREEN |  |  |
| 2418 | 1.8.10.3 | **Cutover Governance M11** |  | 16d | 2025-09-26 | 2025-10-17 |  | 2025-09-26 | 2025-10-22 | 0d | 8d |  |  |  |  | Transition | -687.67 | 6.11 |  | Overdue Start | RED |  |  |
| 2419 | 1.8.10.3.1 | Confirmation of Qualified Parties from Code Bodies |  | 11d | 2025-09-26 | 2025-10-10 | 2417FS+1d | 2025-09-26 | 2025-10-10 | 11d | 8d | 0d |  | Code Bodies,SIT Participants | SI Transition,Code Bodies,SIT Participants | Transition | 330.33 | 6.11 | Matthew Breen | Green | GREEN |  |  |
| 2420 | 1.8.10.3.2 | Self-Declaration that MHHS Functionality will be deployed to Production by Qualified parties | milestone | 0d | 2025-10-10 | 2025-10-10 | 2417FS+12d | 2025-10-10 | 2025-10-10 | 0d | 8d | 0d |  | PP | SI Transition,PP | Transition | 344.71 | 6.11 | Matthew Breen | Green | GREEN |  |  |
| 2421 | 1.8.10.3.3 | Production Service Activation Activities have taken place | milestone | 0d | 2025-10-10 | 2025-10-10 | 2417FS+12d | 2025-10-10 | 2025-10-10 | 0d | 8d | 0d |  | PP | SI Transition,PP | Transition | 344.71 | 6.11 | Matthew Breen | Green | GREEN |  |  |
| 2422 | 1.8.10.3.4 | TORWG (Confirmation of Qualified Parties from TORWG) | milestone | 0d | 2025-10-13 | 2025-10-13 | 2419FS+1d, 2420FS+1d, 2421FS+1d, 2400, 2494, 2498 | 2025-10-13 | 2025-10-13 | 0d | 8d | 0d |  | SI Transition | SI Transition | Transition | 347.71 | 6.11 | Matthew Breen | Green | GREEN |  |  |
| 2423 | 1.8.10.3.5 | MCAG (Provide recommendation to PSG on M11 decision) | milestone | 0d | 2025-10-15 | 2025-10-15 | 2422FS+2d | 2025-10-15 | 2025-10-15 | 0d | 8d | 0d |  | SI Migration | SI Transition,SI Migration | Transition | 349.71 | 6.11 | Matthew Breen | Green | GREEN | T3-MI-0036 | MCAG (Transition) |
| 2424 | 1.8.10.3.6 | PSG (OFGEM and PSG Decision to Confirm M11 and M12) | milestone | 0d | 2025-10-17 | 2025-10-17 | 2423FS+2d | 2025-10-17 | 2025-10-17 | 0d | 8d | 3d |  | SI Transition | SI Transition | Transition | 351.71 | 6.11 | Matthew Breen | Green | GREEN |  |  |

Notes:
- 2411: Guidance: 25/7/24: New Milestone approved at MCAG on 25/7/24. It was initially approved at MCAG on 4/6 but didn't follow the usual process so addded to July MCAG for noting
- 2421: Guidance: 12/8/24: Think this is covered in Service activation prep section below
- 2423: Guidance: 25/7/24: New Milestone approved at MCAG on 25/7/24. It was initially approved at MCAG on 4/6 but didn't follow the usual process so addded to July MCAG for noting

| ID | WBS | Task | Type | Duration | Start | Finish | Predecessors | Complete | Remaining | Baseline start | Baseline finish | Baseline duration | Baseline 1 start | Baseline 1 finish | Total slack | Free slack | Constraint | Baseline cost | Responsible | Involved | Text9 | Task Status | Update Version | MHHS Resource Name | Sched Status | RAG | MHHS Programme Phase |
| --- | --- | --- | --- | --- | --- | --- | --- | --- | --- | --- | --- | --- | --- | --- | --- | --- | --- | --- | --- | --- | --- | --- | --- | --- | --- | --- | --- |
| 2425 | 1.8.11 | **UMS / Advanced Migration** |  | 402d | 2025-10-23 | 2027-05-07 |  |  |  | 2025-10-23 | 2027-05-07 | 391d |  |  | 0d |  |  | -0 | N/A | N/A | Transition | -555.67 | 6.0 | N/A |  |  |  |
| 2426 | 1.8.11.1 | SIT MVC UMS / Advanced Migration |  | 391d | 2025-10-23 | 2027-04-22 | 2499, 2455 |  |  | 2025-10-23 | 2027-04-22 | 391d |  |  | 11d | 0d |  |  |  |  | Transition | 357.33 | 6.0 |  | Green | GREEN |  |
| 2427 | 1.8.11.2 | SIT Non-MVC UMS / Advanced Migration |  | 326d | 2026-01-02 | 2027-04-02 | 2520 |  |  | 2026-01-02 | 2027-04-02 | 326d |  |  | 25d |  |  |  |  |  | Transition | 428.33 | 6.0 |  | Green | GREEN |  |
| 2428 | 1.8.11.3 | Wave 1 UMS / Advanced Migration |  | 251d | 2026-05-15 | 2027-04-30 | 2536 |  |  | 2026-05-15 | 2027-04-30 | 261d |  |  | 5d |  |  |  |  |  | Transition | 561.33 | 6.0 |  | Green | GREEN |  |
| 2429 | 1.8.11.4 | Wave 2 UMS / Advanced Migration |  | 217d | 2026-07-01 | 2027-04-29 | 2560 |  |  | 2026-07-01 | 2027-04-29 | 216d |  |  | 6d |  |  |  |  |  | Transition | 608.33 | 6.0 |  | Green | GREEN |  |
| 2430 | 1.8.11.5 | Wave 3 UMS / Advanced Migration |  | 182d | 2026-08-27 | 2027-05-07 | 2584 |  |  | 2026-08-27 | 2027-05-07 | 181d |  |  | 0d |  |  |  |  |  | Transition | 665.33 | 6.0 |  | Green | GREEN |  |
| 2431 | 1.8.11.6 | Wave 4 UMS / Advanced Migration |  | 136d | 2026-10-23 | 2027-04-30 | 2608 |  |  | 2026-10-23 | 2027-04-30 | 131d |  |  | 5d |  |  |  |  |  | Transition | 722.33 | 6.0 |  | Green | GREEN |  |
| 2432 | 1.8.12 | **Smart / Non-Smart Migration** |  | 402d | 2025-10-23 | 2027-05-07 |  |  |  | 2025-10-23 | 2027-05-07 | 391d |  |  | 0d |  |  | -0 | N/A | N/A | Transition | -555.67 | 6.0 | N/A |  |  |  |
| 2433 | 1.8.12.1 | SIT MVC Smart / Non-Smart Migration |  | 391d | 2025-10-23 | 2027-04-22 | 2499, 2455 |  |  | 2025-10-23 | 2027-04-22 | 391d |  |  | 11d | 0d |  |  |  |  | Transition | 357.33 | 6.0 |  | Green | GREEN |  |
| 2434 | 1.8.12.2 | SIT Non-MVC Smart / Non-Smart Migration |  | 326d | 2026-01-02 | 2027-04-02 | 2520 |  |  | 2026-01-02 | 2027-04-02 | 326d |  |  | 25d |  |  |  |  |  | Transition | 428.33 | 6.0 |  | Green | GREEN |  |
| 2435 | 1.8.12.3 | Wave 1 Smart / Non-Smart Migration |  | 251d | 2026-05-15 | 2027-04-30 | 2536 |  |  | 2026-05-15 | 2027-04-30 | 261d |  |  | 5d |  | start no earlier than 2025-10-03 |  |  |  | Transition | 561.33 | 6.0 |  | Green | GREEN |  |
| 2436 | 1.8.12.4 | Wave 2 Smart / Non-Smart Migration |  | 217d | 2026-07-01 | 2027-04-29 | 2560 |  |  | 2026-07-01 | 2027-04-29 | 216d |  |  | 6d |  |  |  |  |  | Transition | 608.33 | 6.0 |  | Green | GREEN |  |
| 2437 | 1.8.12.5 | Wave 3 Smart / Non-Smart Migration |  | 182d | 2026-08-27 | 2027-05-07 | 2584 |  |  | 2026-08-27 | 2027-05-07 | 181d |  |  | 0d |  |  |  |  |  | Transition | 665.33 | 6.0 |  | Green | GREEN |  |
| 2438 | 1.8.12.6 | Wave 4 Smart / Non-Smart Migration |  | 136d | 2026-10-23 | 2027-04-30 | 2608 |  |  | 2026-10-23 | 2027-04-30 | 131d |  |  | 4d |  |  |  |  |  | Transition | 722.33 | 6.0 |  | Green | GREEN |  |
| 2439 | 1.8.13 | **External Programme Dependency Management** |  | 740d | 2022-10-31 A | 2025-08-29 |  | 66% | 253.44d | 2022-10-31 | 2025-08-29 | 827d | 2022-10-31 | 2025-07-01 | 604d |  |  | -0 | N/A | N/A | Transition |  | 5.0 | N/A |  |  | Migration |
| 2440 | 1.8.13.1 | **BSC Mod P432 & REC CP R0015** |  | 392d | 2022-10-31 A | 2024-04-30 A |  | 100% |  | 2022-10-31 | 2024-04-30 | 827d | 2022-10-31 | 2025-07-01 |  |  |  | -0 | N/A | N/A | Transition |  | 5.0 | N/A |  |  | Migration |
| 2441 | 1.8.13.1.1 | MHHSP engagement with BSCCo until Ofgem decision |  | 316d | 2022-10-31 A | 2024-01-15 A |  | 100% |  | 2022-10-31 | 2024-01-15 | 400d | 2022-10-31 | 2022-12-30 |  |  |  |  | CPT,SRO Function | Code Bodies | Transition |  | 5.0 | MHHS Programme | Complete | COMPLETE | Migration |
| 2442 | 1.8.13.1.2 | Monitor progress and await implementation date |  | 76d | 2024-01-16 A | 2024-04-30 A | 2441 | 100% |  | 2024-01-16 | 2024-04-30 | 652d | 2023-01-02 | 2025-07-01 |  |  |  |  | CPT,SRO Function | Code Bodies | Transition |  | 5.0 | MHHS Programme | Complete | COMPLETE | Migration |
| 2443 | 1.8.13.2 | **BSC Mod P434** |  | 713d | 2022-10-31 A | 2025-07-23 |  | 57% | 310d | 2022-10-31 | 2025-07-23 | 713d | 2022-10-31 | 2025-07-01 | 631d |  |  |  | N/A | N/A | Transition |  | 5.0 | N/A |  |  | Migration |
| 2444 | 1.8.13.2.1 | MHHSP engagement with BSCCo until Ofgem decision |  | 61d | 2022-10-31 A | 2023-01-23 A |  | 100% |  | 2022-10-31 | 2023-01-23 | 61d | 2022-10-31 | 2022-12-30 |  |  |  |  | CPT,SRO Function | Code Bodies | Transition |  | 5.0 | MHHS Programme | Complete | COMPLETE | Migration |
| 2445 | 1.8.13.2.2 | Monitor progress and await implementation date |  | 652d | 2023-01-24 A | 2025-07-23 | 2444 | 52% | 310d | 2023-01-24 | 2025-07-23 | 652d | 2023-01-02 | 2025-07-01 | 631d |  |  |  | CPT,SRO Function | Code Bodies | Transition |  | 5.0 | MHHS Programme | Green | GREEN | Migration |
| 2446 | 1.8.13.3 | **Elexon System Capacity Upgrade** |  | 697d | 2022-10-31 A | 2025-07-01 |  | 58% | 294d | 2022-10-31 | 2025-07-01 | 697d | 2022-10-31 | 2025-07-01 | 647d |  |  |  | N/A | N/A | Transition |  | 5.0 | N/A |  |  | Migration |
| 2447 | 1.8.13.3.1 | Monitor progress to implementation |  | 697d | 2022-10-31 A | 2025-07-01 |  | 58% | 294d | 2022-10-31 | 2025-07-01 | 697d | 2022-10-31 | 2025-07-01 | 647d | 0d |  |  | SI Migration | PP | Transition |  | 5.0 | MHHS Programme | Green | GREEN | Migration |
| 2448 | 1.8.13.3.2 | Implementation date | milestone | 0d | 2025-07-01 | 2025-07-01 | 2447 |  |  | 2025-07-01 | 2025-07-01 | 0d | 2025-07-01 | 2025-07-01 | 647d |  |  |  | PP | SI Migration | Transition | 243.71 | 5.0 | MHHS Programme | Green | GREEN | Migration |

Notes:
- 2428: Guidance: 12/8/24: Made start no earlier, because shorter service actiobal was allowing this to start earlier than the date that had been set
- 2435: Guidance: 12/8/24: Made start no earlier, because shorter service actiobal was allowing this to start earlier than the date that had been set

| ID | WBS | Task | Type | Duration | Start | Finish | Predecessors | Complete | Remaining | Baseline start | Baseline finish | Baseline duration | Baseline 1 start | Baseline 1 finish | Total slack | Free slack | Constraint | Baseline cost | Responsible | Involved | Text9 | Update Version | MHHS Resource Name | MHHS Programme Phase | Task Status | Sched Status | RAG | Milestone ID | Text29 | Tier | Text3 | Notes (2) |
| --- | --- | --- | --- | --- | --- | --- | --- | --- | --- | --- | --- | --- | --- | --- | --- | --- | --- | --- | --- | --- | --- | --- | --- | --- | --- | --- | --- | --- | --- | --- | --- | --- |
| 2449 | 1.8.13.4 | **DCC System Capacity Upgrade** |  | 25d | 2025-07-28 | 2025-08-29 |  |  |  | 2025-07-28 | 2025-08-29 | 25d | 2025-01-13 | 2025-02-14 | 604d |  |  |  | N/A | N/A | Transition | 5.0 | N/A | Migration |  |  |  |  |  |  |  |  |
| 2450 | 1.8.13.4.1 | Assurance of DCC capacity upgrade to ensure suitability to support migration |  | 20d | 2025-07-28 | 2025-08-22 | 1588FF-23d |  |  | 2025-07-28 | 2025-08-22 | 20d | 2025-01-13 | 2025-02-07 | 604d | 0d |  |  | SI Migration | PP | Transition | 5.0 | MHHS Programme | Migration | 270.33 | Green | GREEN |  |  |  |  |  |
| 2451 | 1.8.13.4.2 | DCC Capacity Upgrade Operational | milestone | 0d | 2025-08-29 | 2025-08-29 | 2450FS+5d |  |  | 2025-08-29 | 2025-08-29 | 0d | 2025-02-14 | 2025-02-14 | 604d |  |  |  | PP | SI Migration,IPA | Transition | 5.0 | MHHS Programme | Migration | 302.71 | Green | GREEN | T2-MI-0350 | MCAG | T2 |  |  |
| 2452 | 1.8.14 | **Migration - Tier 1 Milestones** |  | 488d | 2025-09-24 | 2027-08-09 |  |  |  | 2025-09-24 | 2027-08-09 | 477d | 2025-03-07 | 2027-01-05 | 25d |  |  |  | N/A | N/A | Transition | 5.0 | N/A | Migration |  |  |  |  |  |  |  |  |
| 2453 | 1.8.14.1 | Load Shaping Service switched on (M13) | milestone | 0d | 2025-09-24 | 2025-09-24 | 1588 |  |  | 2025-09-24 | 2025-09-24 | 0d | 2025-03-07 | 2025-03-07 | 25d | 0d |  |  | CPT | CPT | Transition | 6.1 | CPT | Migration | 328.71 | Green | GREEN | T1-MI-2000 | PSG | T1 | Load Shaping Service switched on |  |
| 2454 | 1.8.14.2 | Load Shaping Service switched on (M13*) - Late Exit | milestone | 0d | 2025-12-24 | 2025-12-24 | 2453FS+65d |  |  | 2025-12-24 | 2025-12-24 | 0d | 2025-06-06 | 2025-06-06 | 521d |  |  |  | CPT | CPT | Transition | 6.1 | CPT | Migration | 419.71 | Green | GREEN | T2-MI-2500 | PSG | T1 | Load Shaping Service switched on |  |
| 2455 | 1.8.14.3 | Start of 18-month migration for UMS / Advanced (M11) | milestone | 0d | 2025-10-22 | 2025-10-22 | 2453, 2423, 2424, 2499, 1588FS+20d |  |  | 2025-10-22 | 2025-10-22 | 0d | 2025-04-04 | 2025-04-04 | 5d | 0d |  |  | CPT | CPT | Transition | 6.1 | CPT | Migration | 356.71 | Green | GREEN | T1-MI-3000 | PSG | T1 | Start of 1 year migration for UMS / Advanced |  |
| 2456 | 1.8.14.4 | Start of 18-month migration for UMS / Advanced (M11*) - Late Exit | milestone | 0d | 2026-01-21 | 2026-01-21 | 2455FS+65d |  |  | 2026-01-21 | 2026-01-21 | 0d | 2025-07-04 | 2025-07-04 | 501d |  |  |  | CPT | CPT | Transition | 6.1 | CPT | Migration | 447.71 | Green | GREEN | T2-MI-3500 | PSG | T1 | Start of 1 year migration for UMS / Advanced |  |
| 2457 | 1.8.14.5 | Start of 18-month migration for Smart / Non-smart (M12) | milestone | 0d | 2025-10-22 | 2025-10-22 | 2453, 1588FS+20d |  |  | 2025-10-22 | 2025-10-22 | 0d | 2025-04-04 | 2025-04-04 | 501d | 0d |  |  | CPT | CPT | Transition | 6.1 | CPT | Migration | 356.71 | Green | GREEN | T1-MI-4000 | PSG | T1 | Start of 1 year migration for Smart / Non-smart |  |
| 2458 | 1.8.14.6 | Start of 18-month migration for Smart / Non-smart (M12*) - Late Exit | milestone | 0d | 2026-01-21 | 2026-01-21 | 2457FS+65d |  |  | 2026-01-21 | 2026-01-21 | 0d | 2025-07-04 | 2025-07-04 | 501d |  |  |  | CPT | CPT | Transition | 6.1 | CPT | Migration | 447.71 | Green | GREEN | T2-MI-4500 | PSG | T1 | Start of 1 year migration for Smart / Non-smart |  |
| 2459 | 1.8.14.7 | Full transition complete (M15) | milestone | 0d | 2027-05-07 | 2027-05-07 | 2426, 2427, 2428, 2429, 2430, 2431, 2433, 2434, 2435, 2436, 2437, 2438FS+1d |  |  | 2027-05-07 | 2027-05-07 | 0d | 2026-10-05 | 2026-10-05 | 0d |  |  |  | CPT | CPT | Transition | 6.1 | CPT | Migration | 918.71 | Green | GREEN | T1-MI-6000 | PSG | T1 | Full transition complete |  |
| 2460 | 1.8.14.8 | Full transition complete (M15*) - Late Exit | milestone | 0d | 2027-08-09 | 2027-08-09 | 2459FS+66d |  |  | 2027-08-09 | 2027-08-09 | 0d | 2027-01-05 | 2027-01-05 | 98d |  |  |  | CPT | CPT | Transition | 6.1 | CPT | Migration | 1012.71 | Green | GREEN | T2-MI-6500 | PSG | T1 | Full transition complete |  |
| 2461 | 1.9 | **BUSINESS & OPERATIONAL READINESS** |  | 1344d? | 2022-10-31 A | 2027-12-23 |  | 6% | 1268.73d? | 2022-10-31 | 2027-12-23 | 964d | 2023-03-01 | 2026-12-07 | 0d |  |  | -0 | N/A | N/A | Business & Operation Readiness |  | N/A | Business & Operational Readiness |  |  |  |  |  |  |  |  |
| 2462 | 1.9.1 | **Service Management** |  | 983d | 2023-09-19 A | 2027-06-24 |  | 26% | 728.35d | 2023-09-19 | 2027-06-24 | 840d | 2023-03-01 | 2026-12-07 | 130d |  |  | -0 | N/A | N/A | Business & Operation Readiness | 5.0 | N/A | Business & Operational Readiness |  |  |  |  |  |  |  |  |
| 2463 | 1.9.1.1 | **Service Management Strategy** |  | 116d | 2023-09-19 A | 2024-02-27 A |  | 100% |  | 2023-09-19 | 2024-02-27 | 116d | 2023-03-01 | 2023-05-31 |  |  |  | -0 | N/A | N/A | Business & Operation Readiness | 5.0 | N/A | Business & Operational Readiness |  |  |  |  |  |  |  |  |
| 2464 | 1.9.1.1.1 | Develop document with relevant participants (incl. review of the design baseline to ensure service management arrangements are in place across the solution architecture) |  | 84d | 2023-09-19 A | 2024-01-12 A |  | 100% |  | 2023-09-19 | 2024-01-12 | 84d | 2023-03-01 | 2023-04-28 |  |  | start no earlier than 2023-09-19 |  | SI Design |  | Business & Operation Readiness | 5.0 | Matthew Breen | Business & Operational Readiness |  | Complete | COMPLETE |  |  |  |  |  |
| 2465 | 1.9.1.1.2 | Artefact review (via relevant Advisory Group) and updates |  | 31d | 2024-01-15 A | 2024-02-26 A | 2464 | 100% |  | 2024-01-15 | 2024-02-26 | 31d | 2023-05-01 | 2023-05-24 |  |  |  |  | PP | SI Design,IPA | Business & Operation Readiness | 5.0 | Matthew Breen | Business & Operational Readiness |  | Complete | COMPLETE |  |  |  |  |  |
| 2466 | 1.9.1.1.3 | Service Management Strategy approved | milestone | 0d | 2024-02-27 A | 2024-02-27 A | 2465FS+1d | 100% |  | 2024-02-27 | 2024-02-27 | 0d | 2023-05-31 | 2023-05-31 |  |  |  |  | SI Design | PP | Business & Operation Readiness | 5.16 | Matthew Breen | Business & Operational Readiness |  | Complete | COMPLETE | T3-BC-0010 | MCAG | T3 |  |  |
| 2467 | 1.9.1.2 | **Early Life Support Model** |  | 110d | 2024-02-28 A | 2024-07-30 |  | 82% | 20.23d | 2024-02-28 | 2024-07-30 | 110d |  |  | 842d |  |  | -0 | N/A | N/A | Business & Operation Readiness | 5.16 | N/A | Business & Operational Readiness | -441.67 |  |  |  |  |  |  |  |
| 2468 | 1.9.1.2.1 | Draft Document |  | 74d | 2024-02-28 A | 2024-06-10 | 2466 | 96% | 3d | 2024-02-28 | 2024-06-10 | 74d |  |  | 842d | 0d |  |  | SI Transition | SI Transition,PP,SRO | Business & Operation Readiness | 5.24 | Matthew Breen | Business & Operational Readiness |  | Overdue | RED |  |  |  |  |  |
| 2469 | 1.9.1.2.2 | Share document with SRO |  | 1d | 2024-06-11 | 2024-06-11 | 2468 |  |  | 2024-06-11 | 2024-06-11 | 1d |  |  | 842d | 0d |  |  | SI Transition | SI Transition,PP,SRO | Business & Operation Readiness | 5.24 | Matthew Breen | Business & Operational Readiness | -141.67 | Overdue Start | RED |  |  |  |  |  |
| 2470 | 1.9.1.2.3 | Industry Consultation |  | 11d | 2024-06-18 | 2024-07-02 | 2469FS+4d |  |  | 2024-06-18 | 2024-07-02 | 11d |  |  | 842d | 0d |  |  | SI Transition | SI Transition,PP,SRO | Business & Operation Readiness | 5.24 | Matthew Breen | Business & Operational Readiness | -134.67 | Overdue Start | RED |  |  |  |  |  |
| 2471 | 1.9.1.2.4 | Assurance Meeting |  | 1d | 2024-07-16 | 2024-07-16 | 2470FS+9d |  |  | 2024-07-16 | 2024-07-16 | 1d |  |  | 842d | 0d |  |  | SI Transition | SI Transition,PP,SRO | Business & Operation Readiness | 5.24 | Matthew Breen | Business & Operational Readiness | -106.67 | Overdue Start | RED |  |  |  |  |  |
| 2472 | 1.9.1.2.5 | MCAG Approval of Early Life Support Model | milestone | 0d | 2024-07-30 | 2024-07-30 | 2471FS+10d |  |  | 2024-07-30 | 2024-07-30 | 0d |  |  | 842d | 113d |  |  | SI Transition | PP,SRO,SI Transition | Business & Operation Readiness | 5.24 | Matthew Breen | Business & Operational Readiness | -92.29 | Overdue Start | RED | T3-MI-0033 | MCAG (Transition) |  |  | been held with the Code Bodies at the end of August |

Notes:
- 2472: Consultation has been delayed until November 2024.

| ID | WBS | Task | Type | Duration | Start | Finish | Predecessors | Baseline start | Baseline finish | Baseline duration | Baseline 1 start | Baseline 1 finish | Total slack | Free slack | Constraint | Baseline cost | Responsible | Involved | Text9 | Update Version | MHHS Resource Name | MHHS Programme Phase | Task Status | Sched Status | RAG |
| --- | --- | --- | --- | --- | --- | --- | --- | --- | --- | --- | --- | --- | --- | --- | --- | --- | --- | --- | --- | --- | --- | --- | --- | --- | --- |
| 2473 | 1.9.1.3 | **Service Management Arrangements Implementation** |  | 456d | 2025-09-25 | 2027-06-24 |  | 2025-09-25 | 2027-06-24 | 453d | 2025-03-10 | 2026-12-07 | 130d |  |  | -0 | N/A | N/A | Business & Operation Readiness | 5.0 | N/A | Business & Operational Readiness |  |  |  |
| 2474 | 1.9.1.3.1 | Hypercare post M10 |  | 80d | 2025-09-25 | 2026-01-14 | 1588 | 2025-09-25 | 2026-01-14 | 80d | 2025-03-10 | 2025-06-27 | 506d |  |  |  | SI Design | PP | Business & Operation Readiness | 5.0 | Claire Silk | Business & Operational Readiness | 329.33 | Green | GREEN |
| 2475 | 1.9.1.3.2 | Monitor Elexon implementation of Service Management arrangements |  | 436d | 2025-10-23 | 2027-06-24 | 2426SS, 2433SS | 2025-10-23 | 2027-06-24 | 436d | 2025-04-07 | 2026-12-07 | 130d |  |  |  | PP | SI Design | Business & Operation Readiness | 5.0 | Claire Silk | Business & Operational Readiness | 357.33 | Green | GREEN |
| 2476 | 1.9.2 | **Service Activation** |  | 1039d? | 2022-10-31 | 2026-10-22 |  | 2022-10-31 | 2026-10-22 | 289d |  |  | 305d |  |  | -0 | N/A | N/A | Business & Operation Readiness | 5.24 | N/A |  | -555.67 |  |  |
| 2477 | 1.9.2.1 | **SIT MVC** |  | 756d? | 2022-10-31 | 2025-09-22 |  | 2025-02-03 | 2025-09-22 | 0d |  |  | 588d |  |  |  |  |  | Business & Operation Readiness | 5.31 |  |  | -650.67 | Overdue Start | RED |
| 2478 | 1.9.2.1.1 | **SIT MVC Service Activation Preparation Tasks** |  | 20d | 2025-02-03 | 2025-02-28 |  | 2025-02-03 | 2025-02-28 | 0d |  |  | 164d |  |  |  |  |  | Business & Operation Readiness | 5.31 |  |  |  |  |  |
| 2479 | 1.9.2.1.1.1 | Identify operational resources |  | 5d | 2025-02-03 | 2025-02-07 |  | 2025-02-03 | 2025-02-07 | 0d |  |  | 749d |  | finish no earlier than 2025-02-07 |  |  |  | Business & Operation Readiness | 5.31 |  |  | 95.33 | Green | GREEN |
| 2480 | 1.9.2.1.1.2 | Define and approve operational support model |  | 5d | 2025-02-10 | 2025-02-14 |  | 2025-02-10 | 2025-02-14 | 0d |  |  | 744d |  | finish no earlier than 2025-02-14 |  |  |  | Business & Operation Readiness | 5.31 |  |  | 102.33 | Green | GREEN |
| 2481 | 1.9.2.1.1.3 | Confirm SA Training completed |  | 10d | 2025-02-10 | 2025-02-21 |  | 2025-02-10 | 2025-02-21 | 0d |  |  | 739d |  | finish no earlier than 2025-02-21 |  |  |  | Business & Operation Readiness | 5.31 |  |  | 102.33 | Green | GREEN |
| 2482 | 1.9.2.1.1.4 | Participant Engagement / Communications |  | 15d | 2025-02-10 | 2025-02-28 |  | 2025-02-10 | 2025-02-28 | 0d |  |  | 734d |  | finish no earlier than 2025-02-28 |  |  |  | Business & Operation Readiness | 5.31 |  |  | 102.33 | Green | GREEN |
| 2483 | 1.9.2.1.1.5 | Internal Communications |  | 15d | 2025-02-10 | 2025-02-28 |  | 2025-02-10 | 2025-02-28 | 0d |  |  | 734d |  | finish no earlier than 2025-02-28 |  |  |  | Business & Operation Readiness | 5.31 |  |  | 102.33 | Green | GREEN |
| 2484 | 1.9.2.1.1.6 | Validate User Access |  | 5d | 2025-02-17 | 2025-02-21 |  | 2025-02-17 | 2025-02-21 | 0d |  |  | 739d |  | finish no earlier than 2025-02-21 |  |  |  | Business & Operation Readiness | 5.31 |  |  | 109.33 | Green | GREEN |
| 2485 | 1.9.2.1.1.7 | Target Systems and Environments Ready |  | 3d | 2025-02-20 | 2025-02-24 |  | 2025-02-20 | 2025-02-24 | 0d |  |  | 738d |  | finish no earlier than 2025-02-24 |  | HELIX |  | Business & Operation Readiness | 5.31 |  |  | 112.33 | Green | GREEN |
| 2486 | 1.9.2.1.1.8 | Provide opeartional resources with LWIs |  | 5d | 2025-02-17 | 2025-02-21 |  | 2025-02-17 | 2025-02-21 | 0d |  |  | 739d |  | finish no earlier than 2025-02-21 |  |  |  | Business & Operation Readiness | 5.31 |  |  | 109.33 | Green | GREEN |
| 2487 | 1.9.2.1.1.9 | Business Readiness Governance Approval |  | 3d | 2025-02-17 | 2025-02-19 |  | 2025-02-17 | 2025-02-19 | 0d |  |  | 741d |  | finish no earlier than 2025-02-19 |  |  |  | Business & Operation Readiness | 5.31 |  |  | 109.33 | Green | GREEN |
| 2488 | 1.9.2.1.1.10 | SIT MVC Service Activation Preparation Tasks Complete | milestone | 0d | 2025-02-28 | 2025-02-28 |  | 2025-02-28 | 2025-02-28 | 0d |  |  | 144d | 139d | finish no earlier than 2025-02-28 |  |  |  | Business & Operation Readiness | 5.31 |  |  | 120.71 | Green | GREEN |
| 2489 | 1.9.2.1.2 | MHHSP Confirms SIT MVC PPs MHHS Enabled |  | 1d | 2022-10-31 | 2022-10-31 |  | 2025-04-15 | 2025-04-15 | 0d |  |  | 753d | 748d |  |  |  |  | Business & Operation Readiness | 5.28 |  |  | -730.67 | Overdue Start | GREEN |
| 2490 | 1.9.2.1.3 | **SIT MVC Service Activation Implementation** |  | 7d? | 2025-09-12 | 2025-09-22 |  | 2025-09-12 | 2025-09-22 | 0d |  |  | 5d |  |  |  |  |  | Business & Operation Readiness | 5.31 |  |  |  |  |  |
| 2491 | 1.9.2.1.3.1 | Add EDF to DIP |  | 1d | 2025-09-12 | 2025-09-12 | 1784SS, 2489, 2488 | 2025-09-12 | 2025-09-12 | 0d |  |  | 5d | 0d |  |  |  |  | Business & Operation Readiness | 5.31 |  |  | 316.33 | Green | GREEN |
| 2492 | 1.9.2.1.3.2 | DIP Promoted to Production |  | 1d? | 2025-09-15 | 2025-09-15 | 2491 | 2025-09-15 | 2025-09-15 | 0d |  |  | 5d | 0d |  |  |  |  | Business & Operation Readiness | 5.31 |  |  | 319.33 | Green | GREEN |
| 2493 | 1.9.2.1.3.3 | SIT LDSOs Create Certificates and Test Connectivity |  | 1d? | 2025-09-16 | 2025-09-16 | 2492 | 2025-09-16 | 2025-09-16 | 0d |  |  | 5d | 0d |  |  |  |  | Business & Operation Readiness | 5.31 |  |  | 320.33 | Green | GREEN |
| 2494 | 1.9.2.1.3.4 | SIT MVC S&As Create Certificates and Test Connectivity |  | 1d? | 2025-09-16 | 2025-09-16 | 2492 | 2025-09-16 | 2025-09-16 | 0d |  |  | 27d | 19d |  |  |  |  | Business & Operation Readiness | 5.31 |  |  | 320.33 | Green | GREEN |
| 2495 | 1.9.2.1.3.5 | Create M16 in Customer Solution |  | 2d | 2025-09-16 | 2025-09-17 | 2492 | 2025-09-16 | 2025-09-17 | 0d |  |  | 5d | 0d | finish no earlier than 2025-03-07 |  |  |  | Business & Operation Readiness | 5.31 |  |  | 320.33 | Green | GREEN |
| 2496 | 1.9.2.1.3.6 | Publish ISD |  | 2d | 2025-09-18 | 2025-09-19 | 2495 | 2025-09-18 | 2025-09-19 | 0d |  |  | 5d | 0d | finish no earlier than 2025-03-07 |  |  |  | Business & Operation Readiness | 5.31 |  |  | 322.33 | Green | GREEN |
| 2497 | 1.9.2.1.3.7 | SIT LDSOs to update systems with ISD |  | 1d? | 2025-09-22 | 2025-09-22 | 2496 | 2025-09-22 | 2025-09-22 | 0d |  |  | 9d | 1d |  |  |  |  | Business & Operation Readiness | 5.31 |  |  | 326.33 | Green | GREEN |
| 2498 | 1.9.2.1.3.8 | SIT MVC S&As to update systems with ISD |  | 1d? | 2025-09-22 | 2025-09-22 | 2496 | 2025-09-22 | 2025-09-22 | 0d |  |  | 23d | 15d |  |  |  |  | Business & Operation Readiness | 5.31 |  |  | 326.33 | Green | GREEN |
| 2499 | 1.9.2.1.3.9 | SIT MVC Service Activation Implementation Complete | milestone | 0d | 2025-09-19 | 2025-09-19 | 2496 | 2025-09-19 | 2025-09-19 | 0d |  |  | 5d | 0d | finish no earlier than 2025-03-07 |  |  |  | Business & Operation Readiness | 5.31 |  |  | 323.71 | Green | GREEN |

Notes:
- 2474: 10/5: Detail to be added when available
- 2475: 10/5: Detail to be added when available
- 2476: 8/7/24: Likely Servce action will be on a pp by pp basis
- 2489: 8/7/24: For M11 need mcc enabled - need confirmation suppliers agree to being mhhs enabled
- 2495: 18/09/24 - This milestone is consistent with the Service Activation Verison 2.0 Process Map.

| ID | WBS | Task | Type | Duration | Start | Finish | Predecessors | Baseline start | Baseline finish | Baseline duration | Total slack | Free slack | Constraint | Text9 | Update Version | Task Status | Sched Status | RAG | Involved |
| --- | --- | --- | --- | --- | --- | --- | --- | --- | --- | --- | --- | --- | --- | --- | --- | --- | --- | --- | --- |
| 2500 | 1.9.2.1.4 | **SIT MVC Service Activation Implementation MDD** |  | 14d | 2025-03-06 | 2025-03-25 |  | 2025-03-06 | 2025-03-25 | 0d | 717d |  |  | Business & Operation Readiness | 5.31 |  |  |  |  |
| 2501 | 1.9.2.1.4.1 | MDD Manual Load |  | 7d | 2025-03-06 | 2025-03-14 |  | 2025-03-06 | 2025-03-14 | 0d | 724d |  | finish no earlier than 2025-03-14 | Business & Operation Readiness | 5.31 | 126.33 | Green | GREEN |  |
| 2502 | 1.9.2.1.4.2 | MDD Update |  | 8d | 2025-03-14 | 2025-03-25 |  | 2025-03-14 | 2025-03-25 | 0d | 717d |  | finish no earlier than 2025-03-25 | Business & Operation Readiness | 5.31 | 134.33 | Green | GREEN |  |
| 2503 | 1.9.2.1.4.3 | SIT MVC Service Activation Implementation MDD Complete | milestone | 0d | 2025-03-25 | 2025-03-25 |  | 2025-03-25 | 2025-03-25 | 0d | 717d |  | finish no earlier than 2025-03-25 | Business & Operation Readiness | 5.31 | 145.71 | Green | GREEN |  |
| 2504 | 1.9.2.1.5 | **SIT MVC Service Activation Hypercare** |  | 18d | 2025-03-03 | 2025-03-26 |  | 2025-03-03 | 2025-03-26 | 0d | 716d |  |  | Business & Operation Readiness | 5.31 |  |  |  |  |
| 2505 | 1.9.2.1.5.1 | Service & Process Monitoring |  | 18d | 2025-03-03 | 2025-03-26 |  | 2025-03-03 | 2025-03-26 | 0d | 716d |  | finish no earlier than 2025-03-26 | Business & Operation Readiness | 5.31 | 123.33 | Green | GREEN |  |
| 2506 | 1.9.2.1.5.2 | Daily Reporting |  | 18d | 2025-03-03 | 2025-03-26 |  | 2025-03-03 | 2025-03-26 | 0d | 716d |  | finish no earlier than 2025-03-26 | Business & Operation Readiness | 5.31 | 123.33 | Green | GREEN |  |
| 2507 | 1.9.2.1.5.3 | Issue Management |  | 18d | 2025-03-03 | 2025-03-26 |  | 2025-03-03 | 2025-03-26 | 0d | 716d |  | finish no earlier than 2025-03-26 | Business & Operation Readiness | 5.31 | 123.33 | Green | GREEN |  |
| 2508 | 1.9.2.1.5.4 | SA Hypercare Close Down Activities |  | 18d | 2025-03-03 | 2025-03-26 |  | 2025-03-03 | 2025-03-26 | 0d | 716d |  | finish no earlier than 2025-03-26 | Business & Operation Readiness | 5.31 | 123.33 | Green | GREEN |  |
| 2509 | 1.9.2.1.5.5 | Handover to MHHSP |  | 3d | 2025-03-21 | 2025-03-25 |  | 2025-03-21 | 2025-03-25 | 0d | 717d |  | finish no earlier than 2025-03-25 | Business & Operation Readiness | 5.31 | 141.33 | Green | GREEN | MHHSP |
| 2510 | 1.9.2.1.5.6 | SIT MVC Service Activation Hypercare Complete | milestone | 0d | 2025-03-25 | 2025-03-25 |  | 2025-03-25 | 2025-03-25 | 0d | 717d |  | finish no earlier than 2025-03-25 | Business & Operation Readiness | 5.31 | 145.71 | Green | GREEN |  |
| 2511 | 1.9.2.2 | **SIT Non-MVC** |  | 829d | 2022-10-31 | 2026-01-01 |  | 2022-10-31 | 2026-01-01 | 0d | 515d |  |  | Business & Operation Readiness | 5.31 | -650.67 | Overdue Start | RED |  |
| 2512 | 1.9.2.2.1 | **SIT Non-MVC Service Activation Preparation Tasks** |  | 1d | 2022-10-31 | 2022-10-31 |  | 2022-10-31 | 2022-10-31 | 0d | 845d |  |  | Business & Operation Readiness | 5.31 | -651.67 | Overdue Start | RED |  |
| 2513 | 1.9.2.2.1.1 | Helix Preparatory Activities Complete | milestone | 0d | 2022-10-31 | 2022-10-31 |  | 2022-10-31 | 2022-10-31 | 0d | 1344d |  |  | Business & Operation Readiness | 5.29 | -730.67 | Overdue Start | RED |  |
| 2514 | 1.9.2.2.1.2 | MHHSP Confirms SIT Non-MVC PPs MHHS Enabled |  | 1d | 2022-10-31 | 2022-10-31 |  | 2022-10-31 | 2022-10-31 | 0d | 845d | 820d |  | Business & Operation Readiness | 5.28 | -730.67 | Overdue Start | RED |  |
| 2515 | 1.9.2.2.2 | **SIT Non-MVC Service Activation Implementation** |  | 8d | 2025-12-23 | 2026-01-01 |  | 2025-12-23 | 2026-01-01 | 0d | 25d |  |  | Business & Operation Readiness | 5.31 |  |  |  |  |
| 2516 | 1.9.2.2.2.1 | Add EDF to DIP |  | 2d | 2025-12-23 | 2025-12-24 | 1790SS, 2514 | 2025-12-23 | 2025-12-24 | 0d | 25d | 0d | finish no earlier than 2025-06-04 | Business & Operation Readiness | 5.31 | 418.33 | Green | GREEN |  |
| 2517 | 1.9.2.2.2.2 | DIP Promoted to Production |  | 2d | 2025-12-25 | 2025-12-26 | 2516 | 2025-12-25 | 2025-12-26 | 0d | 25d | 0d | finish no earlier than 2025-06-05 | Business & Operation Readiness | 5.31 | 420.33 | Green | GREEN |  |
| 2518 | 1.9.2.2.2.3 | Create M16 in Customer Solution |  | 2d | 2025-12-29 | 2025-12-30 | 2517 | 2025-12-29 | 2025-12-30 | 0d | 25d | 0d | finish no earlier than 2025-06-06 | Business & Operation Readiness | 5.31 | 424.33 | Green | GREEN |  |
| 2519 | 1.9.2.2.2.4 | Publish ISD |  | 2d | 2025-12-31 | 2026-01-01 | 2518 | 2025-12-31 | 2026-01-01 | 0d | 25d | 0d | finish no earlier than 2025-06-06 | Business & Operation Readiness | 5.31 | 426.33 | Green | GREEN |  |
| 2520 | 1.9.2.2.2.5 | SIT Non-MVC Service Activation Implementation Complete | milestone | 0d | 2026-01-01 | 2026-01-01 | 2519 | 2026-01-01 | 2026-01-01 | 0d | 25d | 0d | finish no earlier than 2025-06-06 | Business & Operation Readiness | 5.31 | 427.71 | Green | GREEN |  |
| 2521 | 1.9.2.2.3 | **SIT Non-MVC Service Activation Implementation MDD** |  | 14d | 2025-06-05 | 2025-06-24 |  | 2025-06-05 | 2025-06-24 | 0d | 652d |  |  | Business & Operation Readiness | 5.31 |  |  |  |  |
| 2522 | 1.9.2.2.3.1 | MDD Manual Load |  | 7d | 2025-06-05 | 2025-06-13 |  | 2025-06-05 | 2025-06-13 | 0d | 659d |  | finish no earlier than 2025-06-13 | Business & Operation Readiness | 5.31 | 217.33 | Green | GREEN |  |
| 2523 | 1.9.2.2.3.2 | MDD Update |  | 8d | 2025-06-13 | 2025-06-24 |  | 2025-06-13 | 2025-06-24 | 0d | 652d |  | finish no earlier than 2025-06-24 | Business & Operation Readiness | 5.31 | 225.33 | Green | GREEN |  |
| 2524 | 1.9.2.2.3.3 | SIT Non-MVC Service Activation Implementation MDD Complete | milestone | 0d | 2025-06-24 | 2025-06-24 |  | 2025-06-24 | 2025-06-24 | 0d | 652d |  | finish no earlier than 2025-06-24 | Business & Operation Readiness | 5.31 | 236.71 | Green | GREEN |  |

Notes:
- 2509: Action: 12/8/24: Why is ths a dep into us?
- 2513: Action: 12/8/24: Emailed helix to clarify what needs to go in the prep section and if hypercare is required
- 2514: 8/7/24: Confirm Predecessors

| ID | WBS | Task | Type | Duration | Start | Finish | Predecessors | Baseline start | Baseline finish | Baseline duration | Total slack | Free slack | Constraint | Text9 | Update Version | Task Status | Sched Status | RAG | Involved |
| --- | --- | --- | --- | --- | --- | --- | --- | --- | --- | --- | --- | --- | --- | --- | --- | --- | --- | --- | --- |
| 2525 | 1.9.2.2.4 | **Non-SIT MVC Service Activation Hypercare** |  | 19d | 2025-06-02 | 2025-06-26 |  | 2025-06-02 | 2025-06-26 | 0d | 650d |  |  | Business & Operation Readiness | 5.31 |  |  |  |  |
| 2526 | 1.9.2.2.4.1 | Service& Process Monitoring |  | 18d | 2025-06-02 | 2025-06-25 |  | 2025-06-02 | 2025-06-25 | 0d | 651d |  | finish no earlier than 2025-06-25 | Business & Operation Readiness | 5.31 | 214.33 | Green | GREEN |  |
| 2527 | 1.9.2.2.4.2 | Daily Reporting |  | 18d | 2025-06-02 | 2025-06-25 |  | 2025-06-02 | 2025-06-25 | 0d | 651d |  | finish no earlier than 2025-06-25 | Business & Operation Readiness | 5.31 | 214.33 | Green | GREEN |  |
| 2528 | 1.9.2.2.4.3 | Issue Management |  | 18d | 2025-06-02 | 2025-06-25 |  | 2025-06-02 | 2025-06-25 | 0d | 651d |  | finish no earlier than 2025-06-25 | Business & Operation Readiness | 5.31 | 214.33 | Green | GREEN |  |
| 2529 | 1.9.2.2.4.4 | SA Hypercare Close Down Activities |  | 18d | 2025-06-02 | 2025-06-25 |  | 2025-06-02 | 2025-06-25 | 0d | 651d |  | finish no earlier than 2025-06-25 | Business & Operation Readiness | 5.31 | 214.33 | Green | GREEN |  |
| 2530 | 1.9.2.2.4.5 | Handover to MHHSP |  | 4d | 2025-06-23 | 2025-06-26 |  | 2025-06-23 | 2025-06-26 | 0d | 650d |  | finish no earlier than 2025-06-26 | Business & Operation Readiness | 5.31 | 235.33 | Green | GREEN | MHHSP |
| 2531 | 1.9.2.2.4.6 | Non-SIT MVC Service Activation Hypercare Complete (M) | milestone | 0d | 2025-06-25 | 2025-06-25 |  | 2025-06-25 | 2025-06-25 | 0d | 651d |  | finish no earlier than 2025-06-25 | Business & Operation Readiness | 5.31 | 237.71 | Green | GREEN |  |
| 2532 | 1.9.2.3 | **Wave 1** |  | 924d | 2022-10-31 | 2026-05-14 |  | 2022-10-31 | 2026-05-14 | 0d | 420d |  |  | Business & Operation Readiness | 5.31 | -650.67 | Overdue Start | RED |  |
| 2533 | 1.9.2.3.1 | **SIT Non-MVC Service Activation Preparation Tasks** |  | 924d | 2022-10-31 | 2026-05-14 |  | 2022-10-31 | 2026-05-14 | 0d | 420d |  |  | Business & Operation Readiness | 5.31 | -651.67 | Overdue Start | RED |  |
| 2534 | 1.9.2.3.1.1 | Helix Preparatory Activities Complete | milestone | 0d | 2022-10-31 | 2022-10-31 |  | 2022-10-31 | 2022-10-31 | 0d | 1344d |  |  | Business & Operation Readiness | 5.29 | -730.67 | Overdue Start | RED |  |
| 2535 | 1.9.2.3.1.2 | MHHSP Confirms Wave 1 PPs MHHS Enabled |  | 1d | 2022-10-31 | 2022-10-31 |  | 2022-10-31 | 2022-10-31 | 0d | 904d | 899d |  | Business & Operation Readiness | 5.28 | -730.67 | Overdue Start | RED |  |
| 2536 | 1.9.2.3.1.3 | Wave 1 Service Activation |  | 24d | 2026-04-13 | 2026-05-14 | 1979, 2535 | 2026-04-13 | 2026-05-14 | 25d | 5d | 0d |  | Business & Operation Readiness | 5.24 | 529.33 | Green | GREEN |  |
| 2537 | 1.9.2.3.2 | **Wave 1 - Service Activation Implementation** |  | 5d | 2025-09-01 | 2025-09-05 |  | 2025-09-01 | 2025-09-05 | 0d | 599d |  |  | Business & Operation Readiness | 5.31 |  |  |  |  |
| 2538 | 1.9.2.3.2.1 | MHHSP Enabled Confirmation |  | 2d | 2025-09-01 | 2025-09-02 |  | 2025-09-01 | 2025-09-02 | 0d | 602d |  | finish no earlier than 2025-09-02 | Business & Operation Readiness | 5.31 | 305.33 | Green | GREEN |  |
| 2539 | 1.9.2.3.2.2 | PAB Approval |  | 2d | 2025-09-01 | 2025-09-02 |  | 2025-09-01 | 2025-09-02 | 0d | 602d |  | finish no earlier than 2025-09-02 | Business & Operation Readiness | 5.31 | 305.33 | Green | GREEN |  |
| 2540 | 1.9.2.3.2.3 | Add EDF to DIP |  | 2d | 2025-09-02 | 2025-09-03 |  | 2025-09-02 | 2025-09-03 | 0d | 601d |  | finish no earlier than 2025-09-03 | Business & Operation Readiness | 5.31 | 306.33 | Green | GREEN |  |
| 2541 | 1.9.2.3.2.4 | DIP Promoted to Production |  | 2d | 2025-09-03 | 2025-09-04 |  | 2025-09-03 | 2025-09-04 | 0d | 600d |  | finish no earlier than 2025-09-04 | Business & Operation Readiness | 5.31 | 307.33 | Green | GREEN |  |
| 2542 | 1.9.2.3.2.5 | Create M16 in Customer Solution |  | 2d | 2025-09-04 | 2025-09-05 |  | 2025-09-04 | 2025-09-05 | 0d | 599d |  | finish no earlier than 2025-09-05 | Business & Operation Readiness | 5.31 | 308.33 | Green | GREEN |  |
| 2543 | 1.9.2.3.2.6 | Publish ISD |  | 2d | 2025-09-04 | 2025-09-05 |  | 2025-09-04 | 2025-09-05 | 0d | 599d |  | finish no earlier than 2025-09-05 | Business & Operation Readiness | 5.31 | 308.33 | Green | GREEN |  |
| 2544 | 1.9.2.3.2.7 | Wave 1 - Service Activation Implementation Complete (M) | milestone | 0d | 2025-09-05 | 2025-09-05 |  | 2025-09-05 | 2025-09-05 | 0d | 599d |  | finish no earlier than 2025-09-05 | Business & Operation Readiness | 5.31 | 309.71 | Green | GREEN |  |
| 2545 | 1.9.2.3.3 | **Wave 1 - Service Activation Implementation MDD** |  | 10d | 2025-09-04 | 2025-09-17 |  | 2025-09-04 | 2025-09-17 | 0d | 591d |  |  | Business & Operation Readiness | 5.31 |  |  |  |  |
| 2546 | 1.9.2.3.3.1 | MDD Manual Load |  | 5d | 2025-09-04 | 2025-09-10 |  | 2025-09-04 | 2025-09-10 | 0d | 596d |  | finish no earlier than 2025-09-10 | Business & Operation Readiness | 5.31 | 308.33 | Green | GREEN |  |
| 2547 | 1.9.2.3.3.2 | MDD Update |  | 6d | 2025-09-10 | 2025-09-17 |  | 2025-09-10 | 2025-09-17 | 0d | 591d |  | finish no earlier than 2025-09-17 | Business & Operation Readiness | 5.31 | 314.33 | Green | GREEN |  |
| 2548 | 1.9.2.3.3.3 | Wave 1 - Service Activation Implementation MDD Complete (M) | milestone | 0d | 2025-09-17 | 2025-09-17 |  | 2025-09-17 | 2025-09-17 | 0d | 591d |  | finish no earlier than 2025-09-17 | Business & Operation Readiness | 5.31 | 321.71 | Green | GREEN |  |

Notes:
- 2534: Action: 12/8/24: Emailed helix to clarify what needs to go in the prep section and if hypercare is required
- 2535: 8/7/24: Confirm Predecessors

| ID | WBS | Task | Type | Duration | Start | Finish | Predecessors | Baseline start | Baseline finish | Baseline duration | Total slack | Free slack | Constraint | Text9 | Update Version | Task Status | Sched Status | RAG | Text3 |
| --- | --- | --- | --- | --- | --- | --- | --- | --- | --- | --- | --- | --- | --- | --- | --- | --- | --- | --- | --- |
| 2549 | 1.9.2.3.4 | **Wave 1 - Service Activation Hypercare** |  | 754d | 2022-10-31 | 2025-09-18 |  | 2022-10-31 | 2025-09-18 | 0d | 590d |  |  | Business & Operation Readiness | 5.31 |  |  |  |  |
| 2550 | 1.9.2.3.4.1 | Service& Process Monitoring |  | 14d | 2025-09-01 | 2025-09-18 |  | 2025-09-01 | 2025-09-18 | 0d | 590d |  | finish no earlier than 2025-09-18 | Business & Operation Readiness | 5.31 | 305.33 | Green | GREEN |  |
| 2551 | 1.9.2.3.4.2 | Daily Reporting |  | 14d | 2025-09-01 | 2025-09-18 |  | 2025-09-01 | 2025-09-18 | 0d | 590d |  | finish no earlier than 2025-09-18 | Business & Operation Readiness | 5.31 | 305.33 | Green | GREEN |  |
| 2552 | 1.9.2.3.4.3 | Issue Management |  | 14d | 2025-09-01 | 2025-09-18 |  | 2025-09-01 | 2025-09-18 | 0d | 590d |  | finish no earlier than 2025-09-18 | Business & Operation Readiness | 5.31 | 305.33 | Green | GREEN |  |
| 2553 | 1.9.2.3.4.4 | SA Hypercare Close Down Activities |  | 14d | 2025-09-01 | 2025-09-18 |  | 2025-09-01 | 2025-09-18 | 0d | 590d |  | finish no earlier than 2025-09-18 | Business & Operation Readiness | 5.31 | 305.33 | Green | GREEN |  |
| 2554 | 1.9.2.3.4.5 | Handover to MHHSP |  | 4d | 2025-09-15 | 2025-09-18 |  | 2025-09-15 | 2025-09-18 | 0d | 590d |  | finish no earlier than 2025-09-18 | Business & Operation Readiness | 5.31 | 319.33 | Green | GREEN |  |
| 2555 | 1.9.2.3.4.6 | Non-SIT LDSO Service Activation Hypercare Complete (M) | milestone | 0d | 2022-10-31 | 2022-10-31 |  | 2022-10-31 | 2022-10-31 | 0d | 1344d |  |  | Business & Operation Readiness | 5.31 | -730.67 | Overdue Start | RED | Dates to be confirmed |
| 2556 | 1.9.2.4 | **Wave 2** |  | 957d | 2022-10-31 | 2026-06-30 |  | 2022-10-31 | 2026-06-30 | 0d | 387d |  |  | Business & Operation Readiness | 5.31 | -650.67 | Overdue Start | RED |  |
| 2557 | 1.9.2.4.1 | **SIT Non-MVC Service Activation Preparation Tasks** |  | 957d | 2022-10-31 | 2026-06-30 |  | 2022-10-31 | 2026-06-30 | 0d | 387d |  |  | Business & Operation Readiness | 5.31 | -651.67 | Overdue Start | RED |  |
| 2558 | 1.9.2.4.1.1 | Helix Preparatory Activities Complete | milestone | 0d | 2022-10-31 | 2022-10-31 |  | 2022-10-31 | 2022-10-31 | 0d | 1344d |  |  | Business & Operation Readiness | 5.29 | -730.67 | Overdue Start | RED |  |
| 2559 | 1.9.2.4.1.2 | MHHSP Confirms Wave 2 PPs MHHS Enabled |  | 1d | 2022-10-31 | 2022-10-31 |  | 2022-10-31 | 2022-10-31 | 0d | 938d | 932d |  | Business & Operation Readiness | 5.28 | -730.67 | Overdue Start | RED |  |
| 2560 | 1.9.2.4.1.3 | Wave 2 Service Activation |  | 24d | 2026-05-28 | 2026-06-30 | 2009, 2559 | 2026-05-28 | 2026-06-30 | 25d | 6d | 0d |  | Business & Operation Readiness | 5.24 | 574.33 | Green | GREEN |  |
| 2561 | 1.9.2.4.2 | **Wave 2 - Service Activation Implementation** |  | 5d | 2025-11-03 | 2025-11-07 |  | 2025-11-03 | 2025-11-07 | 0d | 554d |  |  | Business & Operation Readiness | 5.31 |  |  |  |  |
| 2562 | 1.9.2.4.2.1 | MHHSP Enabled Confirmation |  | 2d | 2025-11-03 | 2025-11-04 |  | 2025-11-03 | 2025-11-04 | 0d | 557d |  | finish no earlier than 2025-11-04 | Business & Operation Readiness | 5.31 | 368.33 | Green | GREEN |  |
| 2563 | 1.9.2.4.2.2 | PAB Approval |  | 2d | 2025-11-03 | 2025-11-04 |  | 2025-11-03 | 2025-11-04 | 0d | 557d |  | finish no earlier than 2025-11-04 | Business & Operation Readiness | 5.31 | 368.33 | Green | GREEN |  |
| 2564 | 1.9.2.4.2.3 | Add EDF to DIP |  | 2d | 2025-11-04 | 2025-11-05 |  | 2025-11-04 | 2025-11-05 | 0d | 556d |  | finish no earlier than 2025-11-05 | Business & Operation Readiness | 5.31 | 369.33 | Green | GREEN |  |
| 2565 | 1.9.2.4.2.4 | DIP Promoted to Production |  | 2d | 2025-11-05 | 2025-11-06 |  | 2025-11-05 | 2025-11-06 | 0d | 555d |  | finish no earlier than 2025-11-06 | Business & Operation Readiness | 5.31 | 370.33 | Green | GREEN |  |
| 2566 | 1.9.2.4.2.5 | Create M16 in Customer Solution |  | 2d | 2025-11-06 | 2025-11-07 |  | 2025-11-06 | 2025-11-07 | 0d | 554d |  | finish no earlier than 2025-11-07 | Business & Operation Readiness | 5.31 | 371.33 | Green | GREEN |  |
| 2567 | 1.9.2.4.2.6 | Publish ISD |  | 2d | 2025-11-06 | 2025-11-07 |  | 2025-11-06 | 2025-11-07 | 0d | 554d |  | finish no earlier than 2025-11-07 | Business & Operation Readiness | 5.31 | 371.33 | Green | GREEN |  |
| 2568 | 1.9.2.4.2.7 | Wave 2 - Service Activation Implementation Complete (M) | milestone | 0d | 2025-11-07 | 2025-11-07 |  | 2025-11-07 | 2025-11-07 | 0d | 554d |  | finish no earlier than 2025-11-07 | Business & Operation Readiness | 5.31 | 372.71 | Green | GREEN |  |
| 2569 | 1.9.2.4.3 | **Wave 2 - Service Activation Implementation MDD** |  | 10d | 2025-11-06 | 2025-11-19 |  | 2025-11-06 | 2025-11-19 | 0d | 546d |  |  | Business & Operation Readiness | 5.31 |  |  |  |  |
| 2570 | 1.9.2.4.3.1 | MDD Manual Load |  | 5d | 2025-11-06 | 2025-11-12 |  | 2025-11-06 | 2025-11-12 | 0d | 551d |  | finish no earlier than 2025-11-12 | Business & Operation Readiness | 5.31 | 371.33 | Green | GREEN |  |
| 2571 | 1.9.2.4.3.2 | MDD Update |  | 6d | 2025-11-12 | 2025-11-19 |  | 2025-11-12 | 2025-11-19 | 0d | 546d |  | finish no earlier than 2025-11-19 | Business & Operation Readiness | 5.31 | 377.33 | Green | GREEN |  |
| 2572 | 1.9.2.4.3.3 | Wave 2 - Service Activation Implementation MDD Complete (M) | milestone | 0d | 2025-11-19 | 2025-11-19 |  | 2025-11-19 | 2025-11-19 | 0d | 546d |  | finish no earlier than 2025-11-19 | Business & Operation Readiness | 5.31 | 384.71 | Green | GREEN |  |

Notes:
- 2558: Action: 12/8/24: Emailed helix to clarify what needs to go in the prep section and if hypercare is required
- 2559: 8/7/24: Confirm Predecessors

| ID | WBS | Task | Type | Duration | Start | Finish | Predecessors | Baseline start | Baseline finish | Baseline duration | Total slack | Constraint | Text9 | Update Version | Task Status | Sched Status | RAG | Involved | Text3 |
| --- | --- | --- | --- | --- | --- | --- | --- | --- | --- | --- | --- | --- | --- | --- | --- | --- | --- | --- | --- |
| 2573 | 1.9.2.4.4 | **Wave 2 - Service Activation Hypercare** |  | 14d | 2025-11-03 | 2025-11-20 |  | 2025-11-03 | 2025-11-20 | 0d | 545d |  | Business & Operation Readiness | 5.31 |  |  |  |  |  |
| 2574 | 1.9.2.4.4.1 | Service& Process Monitoring |  | 14d | 2025-11-03 | 2025-11-20 |  | 2025-11-03 | 2025-11-20 | 0d | 545d | finish no earlier than 2025-11-20 | Business & Operation Readiness | 5.31 | 368.33 | Green | GREEN |  |  |
| 2575 | 1.9.2.4.4.2 | Daily Reporting |  | 14d | 2025-11-03 | 2025-11-20 |  | 2025-11-03 | 2025-11-20 | 0d | 545d | finish no earlier than 2025-11-20 | Business & Operation Readiness | 5.31 | 368.33 | Green | GREEN |  |  |
| 2576 | 1.9.2.4.4.3 | Issue Management |  | 14d | 2025-11-03 | 2025-11-20 |  | 2025-11-03 | 2025-11-20 | 0d | 545d | finish no earlier than 2025-11-20 | Business & Operation Readiness | 5.31 | 368.33 | Green | GREEN |  |  |
| 2577 | 1.9.2.4.4.4 | SA Hypercare Close Down Activities |  | 14d | 2025-11-03 | 2025-11-20 |  | 2025-11-03 | 2025-11-20 | 0d | 545d | finish no earlier than 2025-11-20 | Business & Operation Readiness | 5.31 | 368.33 | Green | GREEN |  |  |
| 2578 | 1.9.2.4.4.5 | Handover to MHHSP |  | 4d | 2025-11-17 | 2025-11-20 |  | 2025-11-17 | 2025-11-20 | 0d | 545d | finish no earlier than 2025-11-20 | Business & Operation Readiness | 5.31 | 382.33 | Green | GREEN | MHHSP |  |
| 2579 | 1.9.2.4.4.6 | Wave 2 - Service Activation Hypercare Complete (M) | milestone | 0d | 2025-11-19 | 2025-11-19 |  | 2025-11-19 | 2025-11-19 | 0d | 546d | finish no earlier than 2025-11-19 | Business & Operation Readiness | 5.31 | 384.71 | Green | GREEN |  |  |
| 2580 | 1.9.2.5 | **Wave 3** |  | 998d | 2022-10-31 | 2026-08-26 |  | 2022-10-31 | 2026-08-26 | 0d | 346d |  | Business & Operation Readiness | 5.31 | -650.67 | Overdue Start | RED |  |  |
| 2581 | 1.9.2.5.1 | **SIT Non-MVC Service Activation Preparation Tasks** |  | 998d | 2022-10-31 | 2026-08-26 |  | 2022-10-31 | 2026-08-26 | 0d | 346d |  | Business & Operation Readiness | 5.31 | -651.67 | Overdue Start | RED |  |  |
| 2582 | 1.9.2.5.1.1 | Helix Preparatory Activities Complete | milestone | 0d | 2022-10-31 | 2022-10-31 |  | 2022-10-31 | 2022-10-31 | 0d | 1344d |  | Business & Operation Readiness | 5.29 | -730.67 | Overdue Start | RED |  |  |
| 2583 | 1.9.2.5.1.2 | MHHSP Confirms Wave 3 PPs MHHS Enabled |  | 1d | 2022-10-31 | 2022-10-31 |  | 2022-10-31 | 2022-10-31 | 0d | 973d |  | Business & Operation Readiness | 5.28 | -730.67 | Overdue Start | RED |  |  |
| 2584 | 1.9.2.5.1.3 | Wave 3 Service Activation |  | 24d | 2026-07-24 | 2026-08-26 | 2039, 2583 | 2026-07-24 | 2026-08-26 | 25d | 0d |  | Business & Operation Readiness | 5.24 | 631.33 | Green | GREEN |  |  |
| 2585 | 1.9.2.5.2 | **Wave 3 - Service Activation Implementation** |  | 7d | 2025-12-22 | 2025-12-30 |  | 2025-12-22 | 2025-12-30 | 0d | 517d |  | Business & Operation Readiness | 5.31 |  |  |  |  |  |
| 2586 | 1.9.2.5.2.1 | MHHSP Enabled Confirmation |  | 2d | 2025-12-22 | 2025-12-23 |  | 2025-12-22 | 2025-12-23 | 0d | 522d | finish no earlier than 2025-12-23 | Business & Operation Readiness | 5.31 | 417.33 | Green | GREEN |  |  |
| 2587 | 1.9.2.5.2.2 | PAB Approval |  | 2d | 2025-12-22 | 2025-12-23 |  | 2025-12-22 | 2025-12-23 | 0d | 522d | finish no earlier than 2025-12-23 | Business & Operation Readiness | 5.31 | 417.33 | Green | GREEN |  |  |
| 2588 | 1.9.2.5.2.3 | Add EDF to DIP |  | 2d | 2025-12-23 | 2025-12-24 |  | 2025-12-23 | 2025-12-24 | 0d | 521d | finish no earlier than 2025-12-24 | Business & Operation Readiness | 5.31 | 418.33 | Green | GREEN |  |  |
| 2589 | 1.9.2.5.2.4 | DIP Promoted to Production |  | 2d | 2025-12-29 | 2025-12-30 |  | 2025-12-29 | 2025-12-30 | 0d | 517d | finish no earlier than 2025-12-30 | Business & Operation Readiness | 5.31 | 424.33 | Green | GREEN |  |  |
| 2590 | 1.9.2.5.2.5 | Create M16 in Customer Solution |  | 2d | 2025-12-29 | 2025-12-30 |  | 2025-12-29 | 2025-12-30 | 0d | 517d | finish no earlier than 2025-12-30 | Business & Operation Readiness | 5.31 | 424.33 | Green | GREEN |  |  |
| 2591 | 1.9.2.5.2.6 | Publish ISD |  | 2d | 2025-12-29 | 2025-12-30 |  | 2025-12-29 | 2025-12-30 | 0d | 517d | finish no earlier than 2025-12-30 | Business & Operation Readiness | 5.31 | 424.33 | Green | GREEN |  |  |
| 2592 | 1.9.2.5.2.7 | Wave 3 - Service Activation Implementation Complete (M) | milestone | 0d | 2025-12-30 | 2025-12-30 |  | 2025-12-30 | 2025-12-30 | 0d | 517d | finish no earlier than 2025-12-30 | Business & Operation Readiness | 5.31 | 425.71 | Green | GREEN |  |  |
| 2593 | 1.9.2.5.3 | **Wave 3 - Service Activation Implementation MDD** |  | 839d | 2022-10-31 | 2026-01-15 |  | 2022-10-31 | 2026-01-15 | 0d | 505d |  | Business & Operation Readiness | 5.31 |  |  |  |  |  |
| 2594 | 1.9.2.5.3.1 | MDD Manual Load |  | 7d | 2025-12-29 | 2026-01-06 |  | 2025-12-29 | 2026-01-06 | 0d | 512d | finish no earlier than 2026-01-06 | Business & Operation Readiness | 5.31 | 424.33 | Green | GREEN |  |  |
| 2595 | 1.9.2.5.3.2 | MDD Update |  | 269d | 2025-01-06 | 2026-01-15 |  | 2025-01-06 | 2026-01-15 | 0d | 505d | finish no earlier than 2026-01-15 | Business & Operation Readiness | 5.31 | 67.33 | Green | GREEN |  |  |
| 2596 | 1.9.2.5.3.3 | Wave 3 - Service Activation Implementation MDD Complete (M) | milestone | 0d | 2022-10-31 | 2022-10-31 |  | 2022-10-31 | 2022-10-31 | 0d | 1344d |  | Business & Operation Readiness | 5.31 | -730.67 | Overdue Start | RED |  | Dates to be confirmed |

Notes:
- 2582: Action: 12/8/24: Emailed helix to clarify what needs to go in the prep section and if hypercare is required
- 2583: 8/7/24: Confirm Predecessors

| ID | WBS | Task | Type | Duration | Start | Finish | Predecessors | Baseline start | Baseline finish | Baseline duration | Total slack | Free slack | Constraint | Text9 | Update Version | Task Status | Sched Status | RAG | Involved | Text3 |
| --- | --- | --- | --- | --- | --- | --- | --- | --- | --- | --- | --- | --- | --- | --- | --- | --- | --- | --- | --- | --- |
| 2597 | 1.9.2.5.4 | **Wave 3 - Service Activation Hypercare** |  | 840d | 2022-10-31 | 2026-01-16 |  | 2022-10-31 | 2026-01-16 | 0d | 504d |  |  | Business & Operation Readiness | 5.31 |  |  |  |  |  |
| 2598 | 1.9.2.5.4.1 | Service& Process Monitoring |  | 20d | 2025-12-22 | 2026-01-16 |  | 2025-12-22 | 2026-01-16 | 0d | 504d |  | finish no earlier than 2026-01-16 | Business & Operation Readiness | 5.31 | 417.33 | Green | GREEN |  |  |
| 2599 | 1.9.2.5.4.2 | Daily Reporting |  | 20d | 2025-12-22 | 2026-01-16 |  | 2025-12-22 | 2026-01-16 | 0d | 504d |  | finish no earlier than 2026-01-16 | Business & Operation Readiness | 5.31 | 417.33 | Green | GREEN |  |  |
| 2600 | 1.9.2.5.4.3 | Issue Management |  | 20d | 2025-12-22 | 2026-01-16 |  | 2025-12-22 | 2026-01-16 | 0d | 504d |  | finish no earlier than 2026-01-16 | Business & Operation Readiness | 5.31 | 417.33 | Green | GREEN |  |  |
| 2601 | 1.9.2.5.4.4 | SA Hypercare Close Down Activities |  | 20d | 2025-12-22 | 2026-01-16 |  | 2025-12-22 | 2026-01-16 | 0d | 504d |  | finish no earlier than 2026-01-16 | Business & Operation Readiness | 5.31 | 417.33 | Green | GREEN |  |  |
| 2602 | 1.9.2.5.4.5 | Handover to MHHSP |  | 4d | 2026-01-12 | 2026-01-15 |  | 2026-01-12 | 2026-01-15 | 0d | 505d |  | finish no earlier than 2026-01-15 | Business & Operation Readiness | 5.31 | 438.33 | Green | GREEN | MHHSP |  |
| 2603 | 1.9.2.5.4.6 | Wave 3 Service Activation Hypercare Complete (M) | milestone | 0d | 2022-10-31 | 2022-10-31 |  | 2022-10-31 | 2022-10-31 | 0d | 1344d |  |  | Business & Operation Readiness | 5.31 | -730.67 | Overdue Start | RED |  | Date to be confirmed |
| 2604 | 1.9.2.6 | **Wave 4** |  | 1039d | 2022-10-31 | 2026-10-22 |  | 2022-10-31 | 2026-10-22 | 0d | 305d |  |  | Business & Operation Readiness | 5.31 | -650.67 | Overdue Start | RED |  |  |
| 2605 | 1.9.2.6.1 | **SIT Non-MVC Service Activation Preparation Tasks** |  | 1039d | 2022-10-31 | 2026-10-22 |  | 2022-10-31 | 2026-10-22 | 0d | 305d |  |  | Business & Operation Readiness | 5.31 | -651.67 | Overdue Start | RED |  |  |
| 2606 | 1.9.2.6.1.1 | Helix Preparatory Activities Complete | milestone | 0d | 2022-10-31 | 2022-10-31 |  | 2022-10-31 | 2022-10-31 | 0d | 1344d |  |  | Business & Operation Readiness | 5.29 | -730.67 | Overdue Start | RED |  |  |
| 2607 | 1.9.2.6.1.2 | MHHSP Confirms Wave 4 PPs MHHS Enabled |  | 1d | 2022-10-31 | 2022-10-31 |  | 2022-10-31 | 2022-10-31 | 0d | 1018d | 1014d |  | Business & Operation Readiness | 5.28 | -730.67 | Overdue Start | RED |  |  |
| 2608 | 1.9.2.6.1.3 | Wave 4 Service Activation |  | 24d | 2026-09-21 | 2026-10-22 | 2069, 2607 | 2026-09-21 | 2026-10-22 | 25d | 4d | 0d |  | Business & Operation Readiness | 5.24 | 690.33 | Green | GREEN |  |  |
| 2609 | 1.9.2.6.2 | **Wave 4 - Service Activation Implementation** |  | 265d | 2025-03-03 | 2026-03-06 |  | 2025-03-03 | 2026-03-06 | 0d | 469d |  |  | Business & Operation Readiness | 5.31 |  |  |  |  |  |
| 2610 | 1.9.2.6.2.1 | MHHSP Enabled Confirmation |  | 2d | 2026-03-02 | 2026-03-03 |  | 2026-03-02 | 2026-03-03 | 0d | 472d |  | finish no earlier than 2026-03-03 | Business & Operation Readiness | 5.31 | 487.33 | Green | GREEN |  |  |
| 2611 | 1.9.2.6.2.2 | PAB Approval |  | 1d | 2025-03-03 | 2025-03-03 |  | 2025-03-03 | 2025-03-03 | 0d | 733d |  | finish no earlier than 2025-03-03 | Business & Operation Readiness | 5.31 | 123.33 | Green | GREEN |  |  |
| 2612 | 1.9.2.6.2.3 | Add EDF to DIP |  | 2d | 2026-03-03 | 2026-03-04 |  | 2026-03-03 | 2026-03-04 | 0d | 471d |  | finish no earlier than 2026-03-04 | Business & Operation Readiness | 5.31 | 488.33 | Green | GREEN |  |  |
| 2613 | 1.9.2.6.2.4 | DIP Promoted to Production |  | 2d | 2026-03-04 | 2026-03-05 |  | 2026-03-04 | 2026-03-05 | 0d | 470d |  | finish no earlier than 2026-03-05 | Business & Operation Readiness | 5.31 | 489.33 | Green | GREEN |  |  |
| 2614 | 1.9.2.6.2.5 | Create M16 in Customer Solution |  | 2d | 2026-03-05 | 2026-03-06 |  | 2026-03-05 | 2026-03-06 | 0d | 469d |  | finish no earlier than 2026-03-06 | Business & Operation Readiness | 5.31 | 490.33 | Green | GREEN |  |  |
| 2615 | 1.9.2.6.2.6 | Publish ISD |  | 2d | 2026-03-05 | 2026-03-06 |  | 2026-03-05 | 2026-03-06 | 0d | 469d |  | finish no earlier than 2026-03-06 | Business & Operation Readiness | 5.31 | 490.33 | Green | GREEN |  |  |
| 2616 | 1.9.2.6.2.7 | Wave 4 - Service Activation Implementation Complete (M) | milestone | 0d | 2026-03-06 | 2026-03-06 |  | 2026-03-06 | 2026-03-06 | 0d | 469d |  | finish no earlier than 2026-03-06 | Business & Operation Readiness | 5.31 | 491.71 | Green | GREEN |  |  |
| 2617 | 1.9.2.6.3 | **Wave 4 - Service Activation Implementation MDD** |  | 15d | 2026-03-06 | 2026-03-26 |  | 2026-03-06 | 2026-03-26 | 0d | 455d |  |  | Business & Operation Readiness | 5.31 |  |  |  |  |  |
| 2618 | 1.9.2.6.3.1 | MDD Manual Load |  | 7d | 2026-03-06 | 2026-03-16 |  | 2026-03-06 | 2026-03-16 | 0d | 463d |  | finish no earlier than 2026-03-16 | Business & Operation Readiness | 5.31 | 491.33 | Green | GREEN |  |  |
| 2619 | 1.9.2.6.3.2 | MDD Update |  | 9d | 2026-03-16 | 2026-03-26 |  | 2026-03-16 | 2026-03-26 | 0d | 455d |  | finish no earlier than 2026-03-26 | Business & Operation Readiness | 5.31 | 501.33 | Green | GREEN |  |  |
| 2620 | 1.9.2.6.3.3 | Wave 4 - Service Activation Implementation MDD Complete | milestone | 0d | 2026-03-25 | 2026-03-25 |  | 2026-03-25 | 2026-03-25 | 0d | 456d |  | finish no earlier than 2026-03-25 | Business & Operation Readiness | 5.31 | 510.71 | Green | GREEN |  |  |

Notes:
- 2606: Action: 12/8/24: Emailed helix to clarify what needs to go in the prep section and if hypercare is required
- 2607: 8/7/24: Confirm Predecessors

| ID | WBS | Task | Type | Duration | Start | Finish | Predecessors | Baseline start | Baseline finish | Baseline duration | Total slack | Free slack | Constraint | Text9 | Update Version | Task Status | Sched Status | RAG | Involved | Responsible |
| --- | --- | --- | --- | --- | --- | --- | --- | --- | --- | --- | --- | --- | --- | --- | --- | --- | --- | --- | --- | --- |
| 2621 | 1.9.2.6.4 | **Wave 4 - Service Activation Hypercare** |  | 19d | 2026-03-02 | 2026-03-26 |  | 2026-03-02 | 2026-03-26 | 0d | 455d |  |  | Business & Operation Readiness | 5.31 |  |  |  |  |  |
| 2622 | 1.9.2.6.4.1 | Service& Process Monitoring |  | 19d | 2026-03-02 | 2026-03-26 |  | 2026-03-02 | 2026-03-26 | 0d | 455d |  | finish no earlier than 2026-03-26 | Business & Operation Readiness | 5.31 | 487.33 | Green | GREEN |  |  |
| 2623 | 1.9.2.6.4.2 | Daily Reporting |  | 19d | 2026-03-02 | 2026-03-26 |  | 2026-03-02 | 2026-03-26 | 0d | 455d |  | finish no earlier than 2026-03-26 | Business & Operation Readiness | 5.31 | 487.33 | Green | GREEN |  |  |
| 2624 | 1.9.2.6.4.3 | Issue Management |  | 19d | 2026-03-02 | 2026-03-26 |  | 2026-03-02 | 2026-03-26 | 0d | 455d |  | finish no earlier than 2026-03-26 | Business & Operation Readiness | 5.31 | 487.33 | Green | GREEN |  |  |
| 2625 | 1.9.2.6.4.4 | SA Hypercare Close Down Activities |  | 19d | 2026-03-02 | 2026-03-26 |  | 2026-03-02 | 2026-03-26 | 0d | 455d |  | finish no earlier than 2026-03-26 | Business & Operation Readiness | 5.31 | 487.33 | Green | GREEN |  |  |
| 2626 | 1.9.2.6.4.5 | Handover to MHHSP |  | 4d | 2026-03-02 | 2026-03-05 |  | 2026-03-02 | 2026-03-05 | 0d | 470d |  | finish no earlier than 2026-03-05 | Business & Operation Readiness | 5.31 | 487.33 | Green | GREEN | MHHSP |  |
| 2627 | 1.9.2.6.4.6 | Wave 4 - Service Activation Hypercare Complete (M) | milestone | 0d | 2026-03-25 | 2026-03-25 |  | 2026-03-25 | 2026-03-25 | 0d | 456d |  | finish no earlier than 2026-03-25 | Business & Operation Readiness | 5.31 | 510.71 | Green | GREEN |  |  |
| 2628 | 1.9.2.7 | **Non-SIT LDSO** |  | 741d | 2022-10-31 | 2025-09-01 |  | 2022-10-31 | 2025-09-01 | 0d | 603d |  |  | Business & Operation Readiness | 5.31 | -650.67 | Overdue Start | RED |  |  |
| 2629 | 1.9.2.7.1 | **Non-SIT LDSO Service Activation Data Loading** |  | 176d | 2024-06-07 | 2025-02-07 |  | 2024-06-07 | 2025-02-07 | 0d | 749d |  |  | Business & Operation Readiness | 5.31 |  |  |  |  |  |
| 2630 | 1.9.2.7.1.1 | Define pre Non-SIT LDSO upfront activities |  | 7d | 2024-06-07 | 2024-06-17 |  | 2024-06-07 | 2024-06-17 | 0d | 918d |  | finish no earlier than 2024-06-17 | Business & Operation Readiness | 5.31 | -145.67 | Overdue Start | RED |  |  |
| 2631 | 1.9.2.7.1.2 | **Execute Non-SIT LDSO Activities** |  | 5d | 2025-02-03 | 2025-02-07 |  | 2025-02-03 | 2025-02-07 | 0d | 749d |  |  | Business & Operation Readiness | 5.31 |  |  |  |  |  |
| 2632 | 1.9.2.7.1.2.1 | Create Entity Forms in Customer Solution |  | 3d | 2025-02-03 | 2025-02-05 |  | 2025-02-03 | 2025-02-05 | 0d | 751d |  | finish no earlier than 2025-02-05 | Business & Operation Readiness | 5.31 | 95.33 | Green | GREEN |  | PMP |
| 2633 | 1.9.2.7.1.2.2 | DIP - Promote to Production Environment |  | 3d | 2025-02-03 | 2025-02-05 |  | 2025-02-03 | 2025-02-05 | 0d | 751d |  | finish no earlier than 2025-02-05 | Business & Operation Readiness | 5.31 | 95.33 | Green | GREEN |  | DIP |
| 2634 | 1.9.2.7.1.2.3 | DIP - Enable Technology capabilities for participants |  | 3d | 2025-02-03 | 2025-02-05 |  | 2025-02-03 | 2025-02-05 | 0d | 751d |  | finish no earlier than 2025-02-05 | Business & Operation Readiness | 5.31 | 95.33 | Green | GREEN |  | DIP |
| 2635 | 1.9.2.7.1.2.4 | DIP - Add EFD to DIP |  | 3d | 2025-02-03 | 2025-02-05 |  | 2025-02-03 | 2025-02-05 | 0d | 751d |  | finish no earlier than 2025-02-05 | Business & Operation Readiness | 5.31 | 95.33 | Green | GREEN |  | DIP |
| 2636 | 1.9.2.7.1.2.5 | ISD - Replicate Entity Forms from CS |  | 2d | 2025-02-06 | 2025-02-07 |  | 2025-02-06 | 2025-02-07 | 0d | 749d |  | finish no earlier than 2025-02-07 | Business & Operation Readiness | 5.31 | 98.33 | Green | GREEN |  | HELIX |
| 2637 | 1.9.2.7.1.2.6 | MDD - Load MHHS roles |  | 3d | 2025-02-03 | 2025-02-05 |  | 2025-02-03 | 2025-02-05 | 0d | 751d |  | finish no earlier than 2025-02-05 | Business & Operation Readiness | 5.31 | 95.33 | Green | GREEN |  | PMP |
| 2638 | 1.9.2.7.1.3 | Non-SIT LDSO Service Activation Data Loading Completed (M) | milestone | 0d | 2025-02-07 | 2025-02-07 |  | 2025-02-07 | 2025-02-07 | 0d | 749d |  | finish no earlier than 2025-02-07 | Business & Operation Readiness | 5.31 | 99.71 | Green | GREEN |  |  |
| 2639 | 1.9.2.7.2 | **SIT Non-MVC Service Activation Preparation Tasks** |  | 741d | 2022-10-31 | 2025-09-01 |  | 2022-10-31 | 2025-09-01 | 0d | 603d |  |  | Business & Operation Readiness | 5.31 | -651.67 | Overdue Start | RED |  |  |
| 2640 | 1.9.2.7.2.1 | Helix Preparatory Activities Complete | milestone | 0d | 2022-10-31 | 2022-10-31 |  | 2022-10-31 | 2022-10-31 | 0d | 1344d |  |  | Business & Operation Readiness | 5.29 | -730.67 | Overdue Start | RED |  |  |
| 2641 | 1.9.2.7.2.2 | MHHSP Confirms Non-SIT LDSO PPs MHHS Enabled |  | 1d | 2022-10-31 | 2022-10-31 |  | 2022-10-31 | 2022-10-31 | 0d | 756d | 734d |  | Business & Operation Readiness | 5.28 | -730.67 | Overdue Start | RED |  |  |
| 2642 | 1.9.2.7.2.3 | Non-SIT LDSO Service Activation |  | 6d | 2025-08-25 | 2025-09-01 | 1711, 2641 | 2025-08-25 | 2025-09-01 | 9d | 22d | 17d |  | Business & Operation Readiness | 5.24 | 298.33 | Green | GREEN |  |  |
| 2643 | 1.9.2.7.3 | **Non-SIT LDSO Service Activation Implementation** |  | 4d | 2025-02-24 | 2025-02-27 |  | 2025-02-24 | 2025-02-27 | 0d | 735d |  |  | Business & Operation Readiness | 5.31 |  |  |  |  |  |
| 2644 | 1.9.2.7.3.1 | MHHSP Enabled Confirmation |  | 2d | 2025-02-24 | 2025-02-25 |  | 2025-02-24 | 2025-02-25 | 0d | 737d |  | finish no earlier than 2025-02-25 | Business & Operation Readiness | 5.31 | 116.33 | Green | GREEN |  | MHHSP |
| 2645 | 1.9.2.7.3.2 | PAB Approval |  | 2d | 2025-02-24 | 2025-02-25 |  | 2025-02-24 | 2025-02-25 | 0d | 737d |  | finish no earlier than 2025-02-25 | Business & Operation Readiness | 5.31 | 116.33 | Green | GREEN |  | QUALF |
| 2646 | 1.9.2.7.3.3 | Add EDF to DIP |  | 2d | 2025-02-25 | 2025-02-26 |  | 2025-02-25 | 2025-02-26 | 0d | 736d |  | finish no earlier than 2025-02-26 | Business & Operation Readiness | 5.31 | 117.33 | Green | GREEN |  | DIP |
| 2647 | 1.9.2.7.3.4 | DIP Promoted to Production |  | 2d | 2025-02-26 | 2025-02-27 |  | 2025-02-26 | 2025-02-27 | 0d | 735d |  | finish no earlier than 2025-02-27 | Business & Operation Readiness | 5.31 | 118.33 | Green | GREEN |  | DIP |
| 2648 | 1.9.2.7.3.5 | Create M16 in Customer Solution |  | 2d | 2025-02-26 | 2025-02-27 |  | 2025-02-26 | 2025-02-27 | 0d | 735d |  | finish no earlier than 2025-02-27 | Business & Operation Readiness | 5.31 | 118.33 | Green | GREEN |  | PMP |
| 2649 | 1.9.2.7.3.6 | Publish ISD |  | 2d | 2025-02-26 | 2025-02-27 |  | 2025-02-26 | 2025-02-27 | 0d | 735d |  | finish no earlier than 2025-02-27 | Business & Operation Readiness | 5.31 | 118.33 | Green | GREEN |  |  |
| 2650 | 1.9.2.7.3.7 | Non-SIT LDSO Service Activation Implementation Completed (M) | milestone | 0d | 2025-02-27 | 2025-02-27 |  | 2025-02-27 | 2025-02-27 | 0d | 735d |  | finish no earlier than 2025-02-27 | Business & Operation Readiness | 5.31 | 119.71 | Green | GREEN |  |  |

Notes:
- 2640: Action: 12/8/24: Emailed helix to clarify what needs to go in the prep section and if hypercare is required
- 2641: 8/7/24: Confirm Predecessors

| ID | WBS | Task | Type | Duration | Start | Finish | Predecessors | Baseline start | Baseline finish | Baseline duration | Baseline 1 start | Baseline 1 finish | Total slack | Free slack | Constraint | Baseline cost | Text9 | Update Version | Responsible | Task Status | Sched Status | RAG | Involved | MHHS Resource Name | MHHS Programme Phase | Artefact ID | Action |
| --- | --- | --- | --- | --- | --- | --- | --- | --- | --- | --- | --- | --- | --- | --- | --- | --- | --- | --- | --- | --- | --- | --- | --- | --- | --- | --- | --- |
| 2651 | 1.9.2.7.4 | **Non-SIT LDSO Service Activation Implementation MDD** |  | 14d | 2025-02-27 | 2025-03-18 |  | 2025-02-27 | 2025-03-18 | 0d |  |  | 722d |  |  |  | Business & Operation Readiness | 5.31 |  |  |  |  |  |  |  |  |  |
| 2652 | 1.9.2.7.4.1 | MDD Manual Load |  | 7d | 2025-02-27 | 2025-03-07 |  | 2025-02-27 | 2025-03-07 | 0d |  |  | 729d |  | finish no earlier than 2025-03-07 |  | Business & Operation Readiness | 5.31 | PMP | 119.33 | Green | GREEN |  |  |  |  |  |
| 2653 | 1.9.2.7.4.2 | MDD Update |  | 8d | 2025-03-07 | 2025-03-18 |  | 2025-03-07 | 2025-03-18 | 0d |  |  | 722d |  | finish no earlier than 2025-03-18 |  | Business & Operation Readiness | 5.31 | PMP | 127.33 | Green | GREEN |  |  |  |  |  |
| 2654 | 1.9.2.7.4.3 | Non-SIT LDSO Service Activation Implementation MDD Complete (M) | milestone | 0d | 2025-03-18 | 2025-03-18 |  | 2025-03-18 | 2025-03-18 | 0d |  |  | 722d |  | finish no earlier than 2025-03-18 |  | Business & Operation Readiness | 5.31 |  | 138.71 | Green | GREEN |  |  |  |  |  |
| 2655 | 1.9.2.7.5 | **Non-SIT LDSO Service Activation Hypercare** |  | 18d | 2025-02-24 | 2025-03-19 |  | 2025-02-24 | 2025-03-19 | 0d |  |  | 721d |  |  |  | Business & Operation Readiness | 5.31 |  |  |  |  |  |  |  |  |  |
| 2656 | 1.9.2.7.5.1 | **Non-SIT LDSO Service Activation Hypercare Support** |  | 18d | 2025-02-24 | 2025-03-19 |  | 2025-02-24 | 2025-03-19 | 0d |  |  | 721d |  |  |  | Business & Operation Readiness | 5.31 |  |  |  |  |  |  |  |  |  |
| 2657 | 1.9.2.7.5.1.1 | Service& Process Monitoring |  | 18d | 2025-02-24 | 2025-03-19 |  | 2025-02-24 | 2025-03-19 | 0d |  |  | 721d |  | finish no earlier than 2025-03-19 |  | Business & Operation Readiness | 5.31 |  | 116.33 | Green | GREEN |  |  |  |  |  |
| 2658 | 1.9.2.7.5.1.2 | Daily Reporting |  | 18d | 2025-02-24 | 2025-03-19 |  | 2025-02-24 | 2025-03-19 | 0d |  |  | 721d |  | finish no earlier than 2025-03-19 |  | Business & Operation Readiness | 5.31 |  | 116.33 | Green | GREEN |  |  |  |  |  |
| 2659 | 1.9.2.7.5.1.3 | Issue Management |  | 18d | 2025-02-24 | 2025-03-19 |  | 2025-02-24 | 2025-03-19 | 0d |  |  | 721d |  | finish no earlier than 2025-03-19 |  | Business & Operation Readiness | 5.31 |  | 116.33 | Green | GREEN |  |  |  |  |  |
| 2660 | 1.9.2.7.5.1.4 | SA Hypercare Close Down Activities |  | 18d | 2025-02-24 | 2025-03-19 |  | 2025-02-24 | 2025-03-19 | 0d |  |  | 721d |  | finish no earlier than 2025-03-19 |  | Business & Operation Readiness | 5.31 |  | 116.33 | Green | GREEN |  |  |  |  |  |
| 2661 | 1.9.2.7.5.1.5 | Handover to MHHSP |  | 3d | 2025-03-14 | 2025-03-18 |  | 2025-03-14 | 2025-03-18 | 0d |  |  | 722d |  | finish no earlier than 2025-03-18 |  | Business & Operation Readiness | 5.31 |  | 134.33 | Green | GREEN | MHHSP |  |  |  |  |
| 2662 | 1.9.2.7.5.1.6 | Non-SIT LDSO Service Activation Hypercare Complete (M) | milestone | 0d | 2025-03-18 | 2025-03-18 |  | 2025-03-18 | 2025-03-18 | 0d |  |  | 722d |  | finish no earlier than 2025-03-18 |  | Business & Operation Readiness | 5.31 |  | 138.71 | Green | GREEN |  |  |  |  |  |
| 2663 | 1.9.3 | **Implement Early Life Support Plan** |  | 45d | 2025-01-06 | 2025-03-07 |  | 2025-01-06 | 2025-03-07 | 45d | 2025-01-06 | 2025-02-28 | 729d |  |  | -0 | Business & Operation Readiness | 5.0 | N/A |  |  |  | N/A | N/A | Business & Operational Readiness |  |  |
| 2664 | 1.9.3.1 | Implement Early Life Support Plan |  | 45d | 2025-01-06 | 2025-03-07 | 2472 | 2025-01-06 | 2025-03-07 | 45d | 2025-02-28 | 2025-02-28 | 729d |  | start no earlier than 2025-01-06 |  | Business & Operation Readiness | 5.23 | SI Transition | 67.33 | Green | GREEN | SI Transition,CPT | Matthew Breen | Business & Operational Readiness | MHHS-ART095 |  |
| 2665 | 1.9.4 | **Business Continuity and Disaster Recovery Plan** |  | 40d | 2025-07-31 | 2025-09-24 |  | 2025-07-31 | 2025-09-24 | 40d | 2025-01-13 | 2025-03-07 | 586d |  |  |  | Business & Operation Readiness | 5.0 | N/A |  |  |  | N/A | N/A | Business & Operational Readiness |  |  |
| 2666 | 1.9.4.1 | Central Parties BCDRs in Place |  | 20d | 2025-07-31 | 2025-08-27 | 2206FS-40d | 2025-07-31 | 2025-08-27 | 20d | 2025-01-13 | 2025-02-07 | 586d | 0d |  |  | Business & Operation Readiness | 5.0 | SI Design | 273.33 | Green | GREEN |  | MHHS Programme | Business & Operational Readiness |  |  |
| 2667 | 1.9.4.2 | Risk Based Assurance of Cental Party BCDRs |  | 20d | 2025-08-28 | 2025-09-24 | 2666 | 2025-08-28 | 2025-09-24 | 20d | 2025-02-10 | 2025-03-07 | 586d |  |  |  | Business & Operation Readiness | 5.0 | PP | 301.33 | Green | GREEN | SI Design | MHHS Programme | Business & Operational Readiness |  |  |
| 2668 | 1.9.5 | **Training and Support Materials** |  | 39d | 2025-08-21 | 2025-10-14 |  | 2025-08-21 | 2025-10-14 | 40d | 2025-02-03 | 2025-03-28 | 572d |  |  |  | Business & Operation Readiness | 5.0 | N/A |  |  |  | N/A | N/A | Business & Operational Readiness |  | 10/5: To be reworked with better clarity (LH) |
| 2669 | 1.9.5.1 | Develop document |  | 20d | 2025-08-21 | 2025-09-17 | 2457FS-45d | 2025-08-21 | 2025-09-17 | 20d | 2025-02-03 | 2025-02-28 | 572d | 0d |  |  | Business & Operation Readiness | 5.0 | SI Migration | 294.33 | Green | GREEN | CPT | PPC | Business & Operational Readiness |  |  |
| 2670 | 1.9.5.2 | Document review and update |  | 19d | 2025-09-18 | 2025-10-14 | 2669 | 2025-09-18 | 2025-10-14 | 20d | 2025-03-03 | 2025-03-28 | 572d | 0d |  |  | Business & Operation Readiness | 5.0 | SI Migration | 322.33 | Green | GREEN | PMO,CPT,IPA,PP | PPC | Business & Operational Readiness |  |  |
| 2671 | 1.9.5.3 | Training and Support Materials approved | milestone | 0d | 2025-10-14 | 2025-10-14 | 2670 | 2025-10-14 | 2025-10-14 | 0d | 2025-03-28 | 2025-03-28 | 572d |  |  |  | Business & Operation Readiness | 5.0 | SI Migration | 348.71 | Green | GREEN | PMO,CPT | PPC | Business & Operational Readiness | MHHS-ART118 |  |
| 2672 | 1.9.6 | **PP Business Change** |  | 129d | 2025-02-03 | 2025-07-31 |  | 2025-02-03 | 2025-07-31 | 129d | 2025-02-03 | 2025-07-31 | 625d |  |  |  | Business & Operation Readiness | 5.0 | N/A | M11 |  |  | N/A | N/A | Business & Operational Readiness |  | 10/5: Review with PPC (LH) |
| 2673 | 1.9.6.1 | Plan stakeholder management |  | 129d | 2025-02-03 | 2025-07-31 |  | 2025-02-03 | 2025-07-31 | 129d | 2025-02-03 | 2025-07-31 | 625d |  | start no earlier than 2025-02-03 |  | Business & Operation Readiness | 5.0 | PP | 95.33 | Green | GREEN | PPC | PPC | Business & Operational Readiness |  |  |
| 2674 | 1.9.6.2 | Manage stakeholders |  | 129d | 2025-02-03 | 2025-07-31 |  | 2025-02-03 | 2025-07-31 | 129d | 2025-02-03 | 2025-07-31 | 625d |  | start no earlier than 2025-02-03 |  | Business & Operation Readiness | 5.0 | PP | 95.33 | Green | GREEN | PPC | PPC | Business & Operational Readiness |  |  |
| 2675 | 1.9.6.3 | Develop & implement changes to KPIs, organisation & people management |  | 129d | 2025-02-03 | 2025-07-31 |  | 2025-02-03 | 2025-07-31 | 129d | 2025-02-03 | 2025-07-31 | 625d |  | start no earlier than 2025-02-03 |  | Business & Operation Readiness | 5.0 | PP | 95.33 | Green | GREEN | PPC | PPC | Business & Operational Readiness |  |  |
| 2676 | 1.9.6.4 | Develop & test changes to business processes |  | 129d | 2025-02-03 | 2025-07-31 |  | 2025-02-03 | 2025-07-31 | 129d | 2025-02-03 | 2025-07-31 | 625d |  | start no earlier than 2025-02-03 |  | Business & Operation Readiness | 5.0 | PP | 95.33 | Green | GREEN | PPC | PPC | Business & Operational Readiness |  |  |
| 2677 | 1.9.6.5 | Develop and deliver training |  | 129d | 2025-02-03 | 2025-07-31 |  | 2025-02-03 | 2025-07-31 | 129d | 2025-02-03 | 2025-07-31 | 625d |  | start no earlier than 2025-02-03 |  | Business & Operation Readiness | 5.0 | PP | 95.33 | Green | GREEN | PPC | PPC | Business & Operational Readiness |  |  |
| 2678 | 1.9.6.6 | Programme support for PP Business Change activities |  | 129d | 2025-02-03 | 2025-07-31 |  | 2025-02-03 | 2025-07-31 | 129d | 2025-02-03 | 2025-07-31 | 625d |  | start no earlier than 2025-02-03 |  | Business & Operation Readiness | 5.0 | PPC | 95.33 | Green | GREEN | PP | PPC | Business & Operational Readiness |  |  |

| ID | WBS | Task | Type | Duration | Start | Finish | Predecessors | Baseline start | Baseline finish | Baseline duration | Baseline 1 start | Baseline 1 finish | Total slack | Free slack | Baseline cost | Responsible | Involved | Text9 | Task Status | Update Version | MHHS Resource Name | MHHS Programme Phase | Sched Status | RAG | Milestone ID | Text29 | Tier | Text3 | Artefact ID |
| --- | --- | --- | --- | --- | --- | --- | --- | --- | --- | --- | --- | --- | --- | --- | --- | --- | --- | --- | --- | --- | --- | --- | --- | --- | --- | --- | --- | --- | --- |
| 2679 | 1.9.7 | **Transition to New Settlement Timetable (M16)** |  | 566d | 2025-10-22 | 2027-12-23 |  | 2025-10-22 | 2027-12-23 | 560d |  |  | 0d |  | -0 | N/A | N/A | Business & Operation Readiness | -434.67 | 5.15 | N/A | Business & Operational Readiness |  |  |  |  |  |  |  |
| 2680 | 1.9.7.1 | Elexon to produce Settlement Calendar for Settlement Year 2025/2026 | milestone | 0d | 2025-10-22 | 2025-10-22 | 2455 | 2025-10-22 | 2025-10-22 | 0d |  |  | 5d | 0d |  | PP | PP, Code Bodies | Business & Operation Readiness | 356.71 | 5.15 | Matthew Breen | Business & Operational Readiness | Green | GREEN |  |  |  |  |  |
| 2681 | 1.9.7.2 | Elexon monitor settlement data of migrated MPANs |  | 436d | 2025-10-23 | 2027-06-24 | 2680 | 2025-10-23 | 2027-06-24 | 436d |  |  | 6d |  |  | PP | PP, Code Bodies | Business & Operation Readiness | 357.33 | 5.15 | Matthew Breen | Business & Operational Readiness | Green | GREEN |  |  |  |  |  |
| 2682 | 1.9.7.3 | M16 Checkpoint 1 | milestone | 0d | 2026-06-25 | 2026-06-25 | 2680FS+176d | 2026-06-25 | 2026-06-25 | 0d |  |  | 5d | 0d |  | PP | PP, Code Bodies | Business & Operation Readiness | 602.71 | 5.15 | Matthew Breen | Business & Operational Readiness | Green | GREEN |  |  |  |  |  |
| 2683 | 1.9.7.4 | Confirm if M16 date retained as 07/12/2026 | milestone | 0d | 2026-07-23 | 2026-07-23 | 2682FS+20d | 2026-07-23 | 2026-07-23 | 0d |  |  | 5d | 0d |  | CPT | PP | Business & Operation Readiness | 630.71 | 5.15 | Matthew Breen | Business & Operational Readiness | Green | GREEN |  |  |  |  |  |
| 2684 | 1.9.7.5 | Readiness assessment of participants' readiness to transition to new Settlement Timetable | milestone | 0d | 2026-08-20 | 2026-08-20 | 2683FS+20d | 2026-08-20 | 2026-08-20 | 0d |  |  | 5d | 0d |  | CPT | PP | Business & Operation Readiness | 658.71 | 5.15 | Matthew Breen | Business & Operational Readiness | Green | GREEN |  |  |  |  |  |
| 2685 | 1.9.7.6 | Elexon to produce Settlement Calendar for Settlement Year 2026 up until day before M16 cutover | milestone | 0d | 2026-10-19 | 2026-10-19 | 2684FS+42d | 2026-10-19 | 2026-10-19 | 0d |  |  | 5d | 0d |  | PP | PP, Code Bodies | Business & Operation Readiness | 718.71 | 5.15 | Matthew Breen | Business & Operational Readiness | Green | GREEN |  |  |  |  |  |
| 2686 | 1.9.7.7 | M16 Checkpoint 2 | milestone | 0d | 2027-04-02 | 2027-04-02 | 2685FS+119d | 2027-04-02 | 2027-04-02 | 0d |  |  | 5d | 0d |  | PP | PP, Code Bodies | Business & Operation Readiness | 883.71 | 5.15 | Matthew Breen | Business & Operational Readiness | Green | GREEN |  |  |  |  |  |
| 2687 | 1.9.7.8 | Readiness assessment of participants' readiness to transition to new Settlement Timetable | milestone | 0d | 2027-04-19 | 2027-04-19 | 2686FS+11d | 2027-04-19 | 2027-04-19 | 0d |  |  | 5d | 0d |  | CPT | PP | Business & Operation Readiness | 900.71 | 5.15 | Matthew Breen | Business & Operational Readiness | Green | GREEN |  |  |  |  |  |
| 2688 | 1.9.7.9 | Confirm M16 Date | milestone | 0d | 2027-04-30 | 2027-04-30 | 2687FS+9d | 2027-04-30 | 2027-04-30 | 1d |  |  | 5d | 0d |  | CPT | Code Bodies,CPT,PP,SRO | Business & Operation Readiness | 911.71 | 5.3 | Matthew Breen | Business & Operational Readiness | Green | GREEN | T2-EL-0100 | PSG/BSC PAB | T2 |  |  |
| 2689 | 1.9.7.10 | Raise fast track change to ISD (November publish) | milestone | 0d | 2027-04-30 | 2027-04-30 | 2688 | 2027-04-30 | 2027-04-30 | 0d |  |  | 45d |  |  | PP | PP,CPT,Code Bodies | Business & Operation Readiness | 911.71 | 5.15 | Matthew Breen | Business & Operational Readiness | Green | GREEN |  |  |  |  |  |
| 2690 | 1.9.7.11 | **M16 Approval Window** |  | 129d | 2027-06-25 | 2027-12-23 |  | 2027-06-25 | 2027-12-23 | 124d | 2026-12-07 | 2027-05-24 | 0d |  |  | N/A | N/A | Business & Operation Readiness | 966.71 | 5.0 | N/A | Business & Operational Readiness | Green | GREEN |  |  |  |  |  |
| 2691 | 1.9.7.11.1 | Panel approval that M16 criteria met | milestone | 0d | 2027-06-25 | 2027-06-25 | 2688FS+40d | 2027-06-25 | 2027-06-25 | 0d | 2026-12-07 | 2026-12-07 | 5d |  |  | Panel | Code Bodies,CPT,PP,SRO | Business & Operation Readiness | 967.71 | 5.0 | Matthew Breen | Business & Operational Readiness | Green | GREEN |  |  |  |  |  |
| 2692 | 1.9.7.11.2 | Cut over to new settlement timetable (M16) | milestone | 0d | 2027-07-02 | 2027-07-02 | 2691, 2459FS+40d, 2681, 2689, 2369 | 2027-07-02 | 2027-07-02 | 0d | 2026-12-07 | 2026-12-07 | 0d |  |  | CPT | PP | Business & Operation Readiness | 974.71 | 5.0 | Matthew Breen | Business & Operational Readiness | Green | GREEN | T1-EL-1000 | PSG | T1 |  |  |
| 2693 | 1.9.7.11.3 | Maximum 6-month window for approval of M16 |  | 124d | 2027-07-05 | 2027-12-23 | 2692 | 2027-07-05 | 2027-12-23 | 124d | 2026-12-08 | 2027-05-24 | 0d |  |  | CPT |  | Business & Operation Readiness | 977.33 | 5.0 | Matthew Breen | Business & Operational Readiness | Green | GREEN |  |  |  |  |  |
| 2694 | 1.9.7.11.4 | Cut over to new settlement timetable (M16*) - Late Exit | milestone | 0d | 2027-12-23 | 2027-12-23 | 2693 | 2027-12-23 | 2027-12-23 | 0d | 2027-05-24 | 2027-05-24 | 0d |  |  | CPT | PP | Business & Operation Readiness | 1148.71 | 5.0 | Matthew Breen | Business & Operational Readiness | Green | GREEN | T1-EL-2000 | PSG | T1 |  |  |
| 2695 | 1.10 | **EARLY LIVE RUNNING** |  | 45d | 2027-05-10 | 2027-07-09 |  | 2027-05-10 | 2027-07-09 | 889d | 2024-01-02 | 2027-05-28 | 119d |  |  | N/A | N/A | Business & Operation Readiness |  |  | N/A | Early Live Running |  |  |  |  |  | 1 Nov 2025 - 30 Apr 2026 |  |
| 2696 | 1.10.1 | **Early Live Running Stabilisation Period** |  | 45d | 2027-05-10 | 2027-07-09 |  | 2027-05-10 | 2027-07-09 | 45d | 2026-10-06 | 2026-12-07 | 119d |  |  | N/A | N/A | Business & Operation Readiness |  | 5.0 | N/A | Early Live Running |  |  |  |  |  |  |  |
| 2697 | 1.10.1.1 | Manage Early Live Running stabilisation period |  | 45d | 2027-05-10 | 2027-07-09 | 2459 | 2027-05-10 | 2027-07-09 | 45d | 2026-10-06 | 2026-12-07 | 119d | 0d |  | Code Bodies | PP | Business & Operation Readiness | 921.33 | 5.0 | Matthew Breen | Early Live Running | Green | GREEN |  |  |  |  |  |
| 2698 | 1.10.1.2 | Monitor Early Live Running stabilisation period |  | 45d | 2027-05-10 | 2027-07-09 | 2697SS | 2027-05-10 | 2027-07-09 | 45d | 2026-10-06 | 2026-12-07 | 119d |  |  | SI Migration | Code Bodies,PP | Business & Operation Readiness | 921.33 | 5.0 | Matthew Breen | Early Live Running | Green | GREEN |  |  |  |  |  |
| 2699 | 1.11 | **PROGRAMME CLOSURE** |  | 80d | 2027-03-08 | 2027-06-25 |  | 2027-03-08 | 2027-06-25 | 85d | 2026-08-04 | 2026-11-30 | 129d |  |  | N/A | N/A | Programme Closure |  |  | N/A | Programme Closure |  |  |  |  |  |  |  |
| 2700 | 1.11.1 | **Handover Pack** |  | 80d | 2027-03-08 | 2027-06-25 |  | 2027-03-08 | 2027-06-25 | 85d | 2026-08-04 | 2026-11-30 | 129d |  |  | N/A | N/A | Programme Closure |  | 5.0 | N/A | Programme Closure |  |  |  |  |  |  |  |
| 2701 | 1.11.1.1 | **Draft Handover Pack (for M15)** |  | 40d | 2027-03-08 | 2027-04-30 |  | 2027-03-08 | 2027-04-30 | 40d | 2026-08-04 | 2026-09-28 | 169d |  |  | N/A | N/A | Programme Closure |  | 5.0 | N/A | Programme Closure |  |  |  |  |  |  |  |
| 2702 | 1.11.1.1.1 | Develop document |  | 20d | 2027-03-08 | 2027-04-02 | 2459FS-45d | 2027-03-08 | 2027-04-02 | 20d | 2026-08-04 | 2026-08-31 | 169d | 0d |  | PMO | CPT | Programme Closure | 858.33 | 5.0 |  | Programme Closure | Green | GREEN |  |  |  |  |  |
| 2703 | 1.11.1.1.2 | Document review and update |  | 20d | 2027-04-05 | 2027-04-30 | 2702 | 2027-04-05 | 2027-04-30 | 20d | 2026-09-01 | 2026-09-28 | 169d | 0d |  | SRO | PMO,CPT,IPA,PP | Programme Closure | 886.33 | 5.0 |  | Programme Closure | Green | GREEN |  |  |  |  |  |
| 2704 | 1.11.1.1.3 | Draft Handover Pack approved | milestone | 0d | 2027-04-30 | 2027-04-30 | 2703 | 2027-04-30 | 2027-04-30 | 0d | 2026-09-28 | 2026-09-28 | 169d |  |  | SRO | PMO,CPT | Programme Closure | 911.71 | 5.0 |  | Programme Closure | Green | GREEN |  |  |  |  | MHHS-ART126 |

| ID | WBS | Task | Type | Duration | Start | Finish | Predecessors | Baseline start | Baseline finish | Baseline duration | Baseline 1 start | Baseline 1 finish | Total slack | Free slack | Responsible | Involved | Text9 | Update Version | MHHS Resource Name | MHHS Programme Phase | Task Status | Sched Status | RAG | Artefact ID | Milestone ID | Text29 | Tier |
| --- | --- | --- | --- | --- | --- | --- | --- | --- | --- | --- | --- | --- | --- | --- | --- | --- | --- | --- | --- | --- | --- | --- | --- | --- | --- | --- | --- |
| 2705 | 1.11.1.2 | **Master Handover Pack (for M16)** |  | 40d | 2027-05-03 | 2027-06-25 |  | 2027-05-03 | 2027-06-25 | 40d | 2026-10-06 | 2026-11-30 | 129d |  | N/A | N/A | Programme Closure | 5.0 | N/A | Programme Closure |  |  |  |  |  |  |  |
| 2706 | 1.11.1.2.1 | Update document |  | 20d | 2027-05-03 | 2027-05-28 | 2692FS-45d | 2027-05-03 | 2027-05-28 | 20d | 2026-10-06 | 2026-11-02 | 129d | 0d | PMO | CPT | Programme Closure | 5.0 |  | Programme Closure | 914.33 | Green | GREEN |  |  |  |  |
| 2707 | 1.11.1.2.2 | Document review and update |  | 20d | 2027-05-31 | 2027-06-25 | 2706 | 2027-05-31 | 2027-06-25 | 20d | 2026-11-03 | 2026-11-30 | 129d | 0d | SRO | PMO,CPT,IPA,PP | Programme Closure | 5.0 |  | Programme Closure | 942.33 | Green | GREEN |  |  |  |  |
| 2708 | 1.11.1.2.3 | Master Handover Pack approved | milestone | 0d | 2027-06-25 | 2027-06-25 | 2707 | 2027-06-25 | 2027-06-25 | 0d | 2026-11-30 | 2026-11-30 | 129d |  | SRO | PMO,CPT | Programme Closure | 5.0 |  | Programme Closure | 967.71 | Green | GREEN | MHHS-ART126 |  |  |  |
| 2709 | 1.11.2 | **Programme Lessons Learned** |  | 40d | 2027-03-08 | 2027-04-30 |  | 2027-03-08 | 2027-04-30 | 40d | 2026-08-04 | 2026-09-28 | 169d |  | N/A | N/A | Programme Closure | 5.0 | N/A | Programme Closure |  |  |  |  |  |  |  |
| 2710 | 1.11.2.1 | Develop document |  | 20d | 2027-03-08 | 2027-04-02 | 2459FS-45d | 2027-03-08 | 2027-04-02 | 20d | 2026-08-04 | 2026-08-31 | 169d | 0d | PMO | CPT | Programme Closure | 5.0 |  | Programme Closure | 858.33 | Green | GREEN |  |  |  |  |
| 2711 | 1.11.2.2 | Document review and update |  | 20d | 2027-04-05 | 2027-04-30 | 2710 | 2027-04-05 | 2027-04-30 | 20d | 2026-09-01 | 2026-09-28 | 169d | 0d | SRO | PMO,CPT,IPA | Programme Closure | 5.0 |  | Programme Closure | 886.33 | Green | GREEN |  |  |  |  |
| 2712 | 1.11.2.3 | Programme Lessons Learned document approved | milestone | 0d | 2027-04-30 | 2027-04-30 | 2711 | 2027-04-30 | 2027-04-30 | 0d | 2026-09-28 | 2026-09-28 | 169d |  | SRO | PMO,CPT | Programme Closure | 5.0 |  | Programme Closure | 911.71 | Green | GREEN | MHHS-ART131 |  |  |  |
| 2713 | 1.11.3 | **Programme Closure Report** |  | 40d | 2027-03-08 | 2027-04-30 |  | 2027-03-08 | 2027-04-30 | 40d | 2026-08-04 | 2026-09-28 | 169d |  | N/A | N/A | Programme Closure | 5.0 | N/A | Programme Closure |  |  |  |  |  |  |  |
| 2714 | 1.11.3.1 | Develop document |  | 20d | 2027-03-08 | 2027-04-02 | 2459FS-45d | 2027-03-08 | 2027-04-02 | 20d | 2026-08-04 | 2026-08-31 | 169d | 0d | PMO | CPT | Programme Closure | 5.0 |  | Programme Closure | 858.33 | Green | GREEN |  |  |  |  |
| 2715 | 1.11.3.2 | Document review and update |  | 20d | 2027-04-05 | 2027-04-30 | 2714 | 2027-04-05 | 2027-04-30 | 20d | 2026-09-01 | 2026-09-28 | 169d | 0d | Ofgem | PMO,CPT,IPA,SRO | Programme Closure | 5.0 |  | Programme Closure | 886.33 | Green | GREEN |  |  |  |  |
| 2716 | 1.11.3.3 | Programme Closure Report approved | milestone | 0d | 2027-04-30 | 2027-04-30 | 2715 | 2027-04-30 | 2027-04-30 | 0d | 2026-09-28 | 2026-09-28 | 169d |  | Ofgem | PMO,CPT,IPA,SRO | Programme Closure | 5.0 |  | Programme Closure | 911.71 | Green | GREEN | MHHS-ART130 |  |  |  |
| 2717 | 1.11.4 | **Benefit Realisation Report** |  | 45d | 2027-03-08 | 2027-05-07 |  | 2027-03-08 | 2027-05-07 | 45d | 2026-08-04 | 2026-10-05 | 164d |  | N/A | N/A | Programme Closure | 5.0 | N/A | Programme Closure |  |  |  |  |  |  |  |
| 2718 | 1.11.4.1 | Develop document |  | 20d | 2027-03-08 | 2027-04-02 | 2459FS-45d | 2027-03-08 | 2027-04-02 | 20d | 2026-08-04 | 2026-08-31 | 164d | 0d | PMO | CPT | Programme Closure | 5.0 |  | Programme Closure | 858.33 | Green | GREEN |  |  |  |  |
| 2719 | 1.11.4.2 | Document review and update |  | 20d | 2027-04-05 | 2027-04-30 | 2718 | 2027-04-05 | 2027-04-30 | 20d | 2026-09-01 | 2026-09-28 | 164d | 0d | PP | PMO,CPT,IPA,SRO | Programme Closure | 5.0 |  | Programme Closure | 886.33 | Green | GREEN |  |  |  |  |
| 2720 | 1.11.4.3 | Benefit Realisation Report approved | milestone | 0d | 2027-05-07 | 2027-05-07 | 2719FS+5d | 2027-05-07 | 2027-05-07 | 0d | 2026-10-05 | 2026-10-05 | 164d |  | PMO | CPT,PP,IPA,SRO | Programme Closure | 5.0 |  | Programme Closure | 918.71 | Green | GREEN | MHHS-ART124 | T3-PC-0010 | PSG | T3 |
| 2721 | 1.11.5 | **Operating Model Gap Review with recommendations** |  | 45d | 2027-03-08 | 2027-05-07 |  | 2027-03-08 | 2027-05-07 | 45d | 2026-08-04 | 2026-10-05 | 164d |  | N/A | N/A | Programme Closure | 5.0 | N/A | Programme Closure |  |  |  |  |  |  |  |
| 2722 | 1.11.5.1 | Develop document |  | 20d | 2027-03-08 | 2027-04-02 | 2459FS-45d | 2027-03-08 | 2027-04-02 | 20d | 2026-08-04 | 2026-08-31 | 164d | 0d | PMO | CPT | Programme Closure | 5.0 |  | Programme Closure | 858.33 | Green | GREEN |  |  |  |  |
| 2723 | 1.11.5.2 | Document review and update |  | 20d | 2027-04-05 | 2027-04-30 | 2722 | 2027-04-05 | 2027-04-30 | 20d | 2026-09-01 | 2026-09-28 | 164d | 0d | PP | PMO,CPT,IPA,SRO | Programme Closure | 5.0 |  | Programme Closure | 886.33 | Green | GREEN |  |  |  |  |
| 2724 | 1.11.5.3 | Operating Model Gap Review with recommendations approved | milestone | 0d | 2027-05-07 | 2027-05-07 | 2723FS+5d | 2027-05-07 | 2027-05-07 | 0d | 2026-10-05 | 2026-10-05 | 164d |  | Paul Pettitt | CPT,PP,IPA,SRO | Programme Closure | 5.0 | Paul Pettitt | Programme Closure | 918.71 | Green | GREEN | MHHS-ART128 | T3-PC-0020 | DAG | T3 |
| 2725 | 1.11.6 | **Post-Implementation Review** |  | 45d | 2027-03-08 | 2027-05-07 |  | 2027-03-08 | 2027-05-07 | 45d | 2026-08-04 | 2026-10-05 | 164d |  | N/A | N/A | Programme Closure | 5.0 | N/A | Programme Closure |  |  |  |  |  |  |  |
| 2726 | 1.11.6.1 | Develop document |  | 20d | 2027-03-08 | 2027-04-02 | 2459FS-45d | 2027-03-08 | 2027-04-02 | 20d | 2026-08-04 | 2026-08-31 | 164d | 0d | PMO | CPT | Programme Closure | 5.0 |  | Programme Closure | 858.33 | Green | GREEN |  |  |  |  |
| 2727 | 1.11.6.2 | Document review and update |  | 20d | 2027-04-05 | 2027-04-30 | 2726 | 2027-04-05 | 2027-04-30 | 20d | 2026-09-01 | 2026-09-28 | 164d | 0d | PP | PMO,CPT,IPA,SRO | Programme Closure | 5.0 |  | Programme Closure | 886.33 | Green | GREEN |  |  |  |  |
| 2728 | 1.11.6.3 | Post-Implementation Review approved | milestone | 0d | 2027-05-07 | 2027-05-07 | 2727FS+5d | 2027-05-07 | 2027-05-07 | 0d | 2026-10-05 | 2026-10-05 | 164d |  | PMO | CPT,PP,IPA,SRO | Programme Closure | 5.0 |  | Programme Closure | 918.71 | Green | GREEN | MHHS-ART129 | T3-PC-0030 | PSG | T3 |

Notes:
- 2724: Action: 5/2 - PP said ask MB if belonged to him. MB says doesn't sit with him

| ID | WBS | Task | Type | Duration | Start | Finish | Predecessors | Complete | Remaining | Baseline start | Baseline finish | Baseline duration | Baseline 1 start | Baseline 1 finish | Total slack | Free slack | Constraint | Responsible | Involved | Text9 | Update Version | MHHS Resource Name | MHHS Programme Phase | Task Status | Sched Status | RAG | Artefact ID | Milestone ID | Text29 | Tier | Text3 |
| --- | --- | --- | --- | --- | --- | --- | --- | --- | --- | --- | --- | --- | --- | --- | --- | --- | --- | --- | --- | --- | --- | --- | --- | --- | --- | --- | --- | --- | --- | --- | --- |
| 2729 | 1.11.7 | **Reinforcement Guide** |  | 45d | 2027-03-08 | 2027-05-07 |  |  |  | 2027-03-08 | 2027-05-07 | 45d | 2026-08-04 | 2026-10-05 | 164d |  |  | N/A | N/A | Programme Closure | 5.0 | N/A | Programme Closure |  |  |  |  |  |  |  |  |
| 2730 | 1.11.7.1 | Develop document |  | 20d | 2027-03-08 | 2027-04-02 | 2459FS-45d |  |  | 2027-03-08 | 2027-04-02 | 20d | 2026-08-04 | 2026-08-31 | 164d | 0d |  | PMO | CPT | Programme Closure | 5.0 |  | Programme Closure | 858.33 | Green | GREEN |  |  |  |  |  |
| 2731 | 1.11.7.2 | Document review and update |  | 20d | 2027-04-05 | 2027-04-30 | 2730 |  |  | 2027-04-05 | 2027-04-30 | 20d | 2026-09-01 | 2026-09-28 | 164d | 0d |  | PP | PMO,CPT,IPA,SRO | Programme Closure | 5.0 |  | Programme Closure | 886.33 | Green | GREEN |  |  |  |  |  |
| 2732 | 1.11.7.3 | Reinforcement Guide approved | milestone | 0d | 2027-05-07 | 2027-05-07 | 2731FS+5d |  |  | 2027-05-07 | 2027-05-07 | 0d | 2026-10-05 | 2026-10-05 | 164d |  |  | PMO | CPT,PP,IPA,SRO | Programme Closure | 5.0 |  | Programme Closure | 918.71 | Green | GREEN | MHHS-ART133 | T3-PC-0040 | PSG | T3 |  |
| 2733 | 1.11.8 | **Material and Licenses Transfer** |  | 60d | 2027-04-05 | 2027-06-25 |  |  |  | 2027-04-05 | 2027-06-25 | 60d | 2026-09-08 | 2026-11-30 | 129d |  |  | N/A | N/A | Programme Closure | 5.0 | N/A | Programme Closure |  |  |  |  |  |  |  |  |
| 2734 | 1.11.8.1 | Transfer of Programme material to Elexon and perpetual licenses as appropriate |  | 60d | 2027-04-05 | 2027-06-25 | 2692FF-5d |  |  | 2027-04-05 | 2027-06-25 | 60d | 2026-09-08 | 2026-11-30 | 129d |  |  | PMO | CPT,PP | Programme Closure | 5.0 |  | Programme Closure | 886.33 | Green | GREEN | MHHS-ART139 |  |  |  |  |
| 2735 | 1.12 | **READINESS ASSESSMENTS** |  | 988d | 2023-09-05 A | 2027-06-17 |  | 23% | 764.9d | 2023-09-05 | 2027-06-17 | 849d | 2023-09-11 | 2026-12-04 | 135d |  |  | N/A | N/A | Readiness Assessment |  | N/A | Readiness Assessments |  |  |  |  |  |  |  |  |
| 2736 | 1.12.1 | **Readiness Assessment 3 - Design and Build Progress Check and CP2 Check** |  | 60d | 2023-09-05 A | 2023-11-27 A |  | 100% |  | 2023-09-05 | 2023-11-27 | 50d | 2023-09-11 | 2023-11-17 |  |  |  | N/A | N/A | Readiness Assessment | 5.5 | N/A | Readiness Assessments | M5,M6 |  |  |  |  |  |  |  |
| 2737 | 1.12.1.1 | Launch Readiness Assessment survey | milestone | 0d | 2023-09-05 A | 2023-09-05 A | 1320FS-40d | 100% |  | 2023-09-05 | 2023-09-05 | 0d | 2023-09-11 | 2023-09-11 |  |  |  | PPC |  | Readiness Assessment | 5.5 | PPC | Readiness Assessments |  | Complete | COMPLETE |  |  |  |  |  |
| 2738 | 1.12.1.2 | PPs submit survey responses |  | 15d | 2023-09-05 A | 2023-09-25 A | 2737 | 100% |  | 2023-09-05 | 2023-09-25 | 15d | 2023-09-11 | 2023-09-29 |  |  |  | PP | PPC | Readiness Assessment | 5.5 | PPC | Readiness Assessments |  | Complete | COMPLETE |  |  |  |  |  |
| 2739 | 1.12.1.3 | Analyse survey responses |  | 15d | 2023-09-26 A | 2023-10-16 A | 2738 | 100% |  | 2023-09-26 | 2023-10-16 | 15d | 2023-10-02 | 2023-10-20 |  |  |  | PPC | CPT | Readiness Assessment | 5.5 | PPC | Readiness Assessments |  | Complete | COMPLETE |  |  |  |  |  |
| 2740 | 1.12.1.4 | Conduct deep-dive interviews (sample of PPs) |  | 15d | 2023-09-26 A | 2023-10-16 A | 2738 | 100% |  | 2023-09-26 | 2023-10-16 | 15d | 2023-10-02 | 2023-10-20 |  |  |  | PPC | CPT | Readiness Assessment | 5.5 | PPC | Readiness Assessments |  | Complete | COMPLETE |  |  |  |  |  |
| 2741 | 1.12.1.5 | Produce Readiness Assessment Reports (Overall Report & Individual Participant Reports) |  | 25d | 2023-10-17 A | 2023-11-20 A | 2739, 2740 | 100% |  | 2023-10-17 | 2023-11-20 | 15d | 2023-10-23 | 2023-11-10 |  |  |  | PPC |  | Readiness Assessment | 5.5 | PPC | Readiness Assessments |  | Complete | COMPLETE |  |  |  |  |  |
| 2742 | 1.12.1.6 | Readiness Assessment 3 - Design & Build Checkpoint 1 - Completed (incl. Readiness Assessment Report approval) | milestone | 0d | 2023-11-27 A | 2023-11-27 A | 2741FS+5d | 100% |  | 2023-11-27 | 2023-11-27 | 0d | 2023-11-17 | 2023-11-17 |  |  |  | CPT | PPC | Readiness Assessment | 5.13 | PPC | Readiness Assessments |  | Complete | COMPLETE |  | T2-RA-0200 | PSG | T2 |  |
| 2743 | 1.12.2 | **Readiness Assessment 5 / 6 - Start of Qualification and Participant Readiness for M10 and M11 and CP3/CP4 check** |  | 47d | 2025-04-21 | 2025-06-24 |  |  |  | 2025-04-21 | 2025-06-24 | 49d | 2024-11-12 | 2025-01-17 | 652d |  |  | N/A | N/A | Readiness Assessment | 5.0 | N/A | Readiness Assessments | M11 |  |  |  |  |  |  | D25 - RA6 Readiness Report |
| 2744 | 1.12.2.1 | Launch Readiness Assessment survey | milestone | 0d | 2025-04-21 | 2025-04-21 |  |  |  | 2025-04-21 | 2025-04-21 | 0d | 2024-11-12 | 2024-11-12 | 652d | 0d | start no earlier than 2025-04-21 | PPC |  | Readiness Assessment | 5.0 | PPC | Readiness Assessments | 172.33 | Green | GREEN |  |  |  |  |  |
| 2745 | 1.12.2.2 | PPs submit survey responses |  | 15d | 2025-04-21 | 2025-05-09 | 2744 |  |  | 2025-04-21 | 2025-05-09 | 15d | 2024-11-12 | 2024-12-02 | 652d | 0d |  | PP | PPC | Readiness Assessment | 5.0 | PPC | Readiness Assessments | 172.33 | Green | GREEN |  |  |  |  |  |
| 2746 | 1.12.2.3 | Analyse survey responses |  | 15d | 2025-05-12 | 2025-05-30 | 2745 |  |  | 2025-05-12 | 2025-05-30 | 15d | 2024-12-03 | 2024-12-23 | 652d | 0d |  | PPC | CPT | Readiness Assessment | 5.0 | PPC | Readiness Assessments | 193.33 | Green | GREEN |  |  |  |  |  |
| 2747 | 1.12.2.4 | Conduct deep-dive interviews (sample of PPs) |  | 15d | 2025-05-12 | 2025-05-30 | 2745 |  |  | 2025-05-12 | 2025-05-30 | 15d | 2024-12-03 | 2024-12-23 | 652d | 0d |  | PPC | CPT | Readiness Assessment | 5.0 | PPC | Readiness Assessments | 193.33 | Green | GREEN |  |  |  |  |  |
| 2748 | 1.12.2.5 | Produce Readiness Assessment Reports (Overall Report & Individual Participant Reports) |  | 15d | 2025-06-02 | 2025-06-20 | 2746, 2747 |  |  | 2025-06-02 | 2025-06-20 | 15d | 2024-12-24 | 2025-01-13 | 652d | 0d |  | PPC |  | Readiness Assessment | 5.0 | PPC | Readiness Assessments | 214.33 | Green | GREEN |  |  |  |  |  |
| 2749 | 1.12.2.6 | Readiness Assessment 5 / 6 - Start of Qualification and Participant Readiness for M10 and M11 and CP3/CP4 check (incl. Readiness Assessment Report approval) Completed | milestone | 0d | 2025-06-24 | 2025-06-24 | 2748FS+2d |  |  | 2025-06-24 | 2025-06-24 | 0d | 2025-01-17 | 2025-01-17 | 652d | 0d |  | CPT | PPC | Readiness Assessment | 5.18 | PPC | Readiness Assessments | 236.71 | Green | GREEN |  | T2-RA-0400 | PSG | T2 |  |
| 2750 | 1.12.3 | **Readiness Assessment 7 - Migration Checkpoint** |  | 49d | 2026-01-12 | 2026-03-19 |  |  |  | 2026-01-12 | 2026-03-19 | 49d | 2025-08-04 | 2025-10-09 | 460d |  |  | N/A | N/A | Readiness Assessment | 5.0 | N/A | Readiness Assessments | M14 |  |  |  |  |  |  | D29 - RA8 Readiness Report |
| 2751 | 1.12.3.1 | Launch Readiness Assessment survey | milestone | 0d | 2026-01-12 | 2026-01-12 |  |  |  | 2026-01-12 | 2026-01-12 | 0d | 2025-08-04 | 2025-08-04 | 460d | 0d | start no earlier than 2026-01-12 | PPC |  | Readiness Assessment | 5.0 | PPC | Readiness Assessments | 438.33 | Green | GREEN |  |  |  |  |  |
| 2752 | 1.12.3.2 | PPs submit survey responses |  | 15d | 2026-01-12 | 2026-01-30 | 2751 |  |  | 2026-01-12 | 2026-01-30 | 15d | 2025-08-04 | 2025-08-22 | 460d | 0d |  | PP | PPC | Readiness Assessment | 5.0 | PPC | Readiness Assessments | 438.33 | Green | GREEN |  |  |  |  |  |
| 2753 | 1.12.3.3 | Analyse survey responses |  | 15d | 2026-02-02 | 2026-02-20 | 2752 |  |  | 2026-02-02 | 2026-02-20 | 15d | 2025-08-25 | 2025-09-12 | 460d | 0d |  | PPC | CPT | Readiness Assessment | 5.0 | PPC | Readiness Assessments | 459.33 | Green | GREEN |  |  |  |  |  |
| 2754 | 1.12.3.4 | Conduct deep-dive interviews (sample of PPs) |  | 15d | 2026-02-02 | 2026-02-20 | 2752 |  |  | 2026-02-02 | 2026-02-20 | 15d | 2025-08-25 | 2025-09-12 | 460d | 0d |  | PPC | CPT | Readiness Assessment | 5.0 | PPC | Readiness Assessments | 459.33 | Green | GREEN |  |  |  |  |  |
| 2755 | 1.12.3.5 | Produce Readiness Assessment Reports (Overall Report & Individual Participant Reports) |  | 15d | 2026-02-23 | 2026-03-13 | 2753, 2754 |  |  | 2026-02-23 | 2026-03-13 | 15d | 2025-09-15 | 2025-10-03 | 460d | 0d |  | PPC |  | Readiness Assessment | 5.0 | PPC | Readiness Assessments | 480.33 | Green | GREEN |  |  |  |  |  |
| 2756 | 1.12.3.6 | Readiness Assessment 7 - Migration Checkpoint - Completed (incl. Readiness Assessment Report approval) | milestone | 0d | 2026-03-19 | 2026-03-19 | 2755FS+4d |  |  | 2026-03-19 | 2026-03-19 | 0d | 2025-10-09 | 2025-10-09 | 460d | 0d |  | CPT | PPC | Readiness Assessment | 5.0 | PPC | Readiness Assessments | 504.71 | Green | GREEN |  | T2-RA-0600 | PSG | T2 |  |

Notes:
- 2740: 16/11- FD confirmed activity didn't take place for RA3 because responses did not warrant follow-up
- 2742: 16/11-RA3 outputs and initial findings shared with PSG to support M9 decision making. Individual reports and final closure report being finalised. No impact to Programme timelines or activities
- 2749: 08/02/2024 Name change approval at PSG on 07/02/24 from 'Readiness Assessment 5 - Start of Qualification - Completed (incl. Readiness Assessment Report approval)'

| ID | WBS | Task | Type | Duration | Start | Finish | Predecessors | Complete | Remaining | Baseline start | Baseline finish | Baseline duration | Baseline 1 start | Baseline 1 finish | Total slack | Free slack | Constraint | Responsible | Involved | Text3 | Text9 | Task Status | Update Version | MHHS Resource Name | MHHS Programme Phase | Sched Status | RAG | Milestone ID | Text29 | Tier |
| --- | --- | --- | --- | --- | --- | --- | --- | --- | --- | --- | --- | --- | --- | --- | --- | --- | --- | --- | --- | --- | --- | --- | --- | --- | --- | --- | --- | --- | --- | --- |
| 2757 | 1.12.4 | **Readiness Assessment 8 - Ready to Accept New MPANs** |  | 49d | 2026-08-06 | 2026-10-13 |  |  |  | 2026-08-06 | 2026-10-13 | 49d | 2026-01-06 | 2026-03-13 | 312d |  |  | N/A | N/A | D29 - RA8 Readiness Report | Readiness Assessment | M14 | 5.0 | N/A | Readiness Assessments |  |  |  |  |  |
| 2758 | 1.12.4.1 | Launch Readiness Assessment survey | milestone | 0d | 2026-08-06 | 2026-08-06 | 2071FS-60d |  |  | 2026-08-06 | 2026-08-06 | 0d | 2026-01-06 | 2026-01-06 | 312d | 0d |  | PPC |  |  | Readiness Assessment | 644.33 | 5.0 | PPC | Readiness Assessments | Green | GREEN |  |  |  |
| 2759 | 1.12.4.2 | PPs submit survey responses |  | 15d | 2026-08-06 | 2026-08-26 | 2758 |  |  | 2026-08-06 | 2026-08-26 | 15d | 2026-01-06 | 2026-01-26 | 312d | 0d |  | PP | PPC |  | Readiness Assessment | 644.33 | 5.0 | PPC | Readiness Assessments | Green | GREEN |  |  |  |
| 2760 | 1.12.4.3 | Analyse survey responses |  | 15d | 2026-08-27 | 2026-09-16 | 2759 |  |  | 2026-08-27 | 2026-09-16 | 15d | 2026-01-27 | 2026-02-16 | 312d | 0d |  | PPC | CPT |  | Readiness Assessment | 665.33 | 5.0 | PPC | Readiness Assessments | Green | GREEN |  |  |  |
| 2761 | 1.12.4.4 | Conduct deep-dive interviews (sample of PPs) |  | 15d | 2026-08-27 | 2026-09-16 | 2759 |  |  | 2026-08-27 | 2026-09-16 | 15d | 2026-01-27 | 2026-02-16 | 312d | 0d |  | PPC | CPT |  | Readiness Assessment | 665.33 | 5.0 | PPC | Readiness Assessments | Green | GREEN |  |  |  |
| 2762 | 1.12.4.5 | Produce Readiness Assessment Reports (Overall Report & Individual Participant Reports) |  | 15d | 2026-09-17 | 2026-10-07 | 2760, 2761 |  |  | 2026-09-17 | 2026-10-07 | 15d | 2026-02-17 | 2026-03-09 | 312d | 0d |  | PPC |  |  | Readiness Assessment | 686.33 | 5.0 | PPC | Readiness Assessments | Green | GREEN |  |  |  |
| 2763 | 1.12.4.6 | Readiness Assessment 8 - Ready to Accept New MPANs - Completed (incl. Readiness Assessment Report approval) | milestone | 0d | 2026-10-13 | 2026-10-13 | 2762FS+4d |  |  | 2026-10-13 | 2026-10-13 | 0d | 2026-03-13 | 2026-03-13 | 312d | 0d |  | CPT | PPC |  | Readiness Assessment | 712.71 | 5.0 | PPC | Readiness Assessments | Green | GREEN | T2-RA-0700 | PSG | T2 |
| 2764 | 1.12.5 | **Readiness Assessment 9 - Ready for New Settlement Timetable and CP5 Check** |  | 49d | 2027-04-12 | 2027-06-17 |  |  |  | 2027-04-12 | 2027-06-17 | 49d | 2026-09-29 | 2026-12-04 | 135d |  |  | N/A | N/A | D32 - RA10 Readiness Report | Readiness Assessment | M16 | 5.0 | N/A | Readiness Assessments |  |  |  |  |  |
| 2765 | 1.12.5.1 | Launch Readiness Assessment survey | milestone | 0d | 2027-04-12 | 2027-04-12 | 2692FS-60d |  |  | 2027-04-12 | 2027-04-12 | 0d | 2026-09-29 | 2026-09-29 | 135d | 0d |  | PPC |  |  | Readiness Assessment | 893.33 | 5.0 | PPC | Readiness Assessments | Green | GREEN |  |  |  |
| 2766 | 1.12.5.2 | PPs submit survey responses |  | 15d | 2027-04-12 | 2027-04-30 | 2765 |  |  | 2027-04-12 | 2027-04-30 | 15d | 2026-09-29 | 2026-10-19 | 135d | 0d |  | PP | PPC |  | Readiness Assessment | 893.33 | 5.0 | PPC | Readiness Assessments | Green | GREEN |  |  |  |
| 2767 | 1.12.5.3 | Analyse survey responses |  | 15d | 2027-05-03 | 2027-05-21 | 2766 |  |  | 2027-05-03 | 2027-05-21 | 15d | 2026-10-20 | 2026-11-09 | 135d | 0d |  | PPC | CPT |  | Readiness Assessment | 914.33 | 5.0 | PPC | Readiness Assessments | Green | GREEN |  |  |  |
| 2768 | 1.12.5.4 | Conduct deep-dive interviews (sample of PPs) |  | 15d | 2027-05-03 | 2027-05-21 | 2766 |  |  | 2027-05-03 | 2027-05-21 | 15d | 2026-10-20 | 2026-11-09 | 135d | 0d |  | PPC | CPT |  | Readiness Assessment | 914.33 | 5.0 | PPC | Readiness Assessments | Green | GREEN |  |  |  |
| 2769 | 1.12.5.5 | Produce Readiness Assessment Reports (Overall Report & Individual Participant Reports) |  | 15d | 2027-05-24 | 2027-06-11 | 2767, 2768 |  |  | 2027-05-24 | 2027-06-11 | 15d | 2026-11-10 | 2026-11-30 | 135d | 0d |  | PPC |  |  | Readiness Assessment | 935.33 | 5.0 | PPC | Readiness Assessments | Green | GREEN |  |  |  |
| 2770 | 1.12.5.6 | Readiness Assessment 9 - Readiness for New Settlement Timetable - Completed (incl. Readiness Assessment Report approval) | milestone | 0d | 2027-06-17 | 2027-06-17 | 2769FS+4d |  |  | 2027-06-17 | 2027-06-17 | 0d | 2026-12-04 | 2026-12-04 | 135d | 0d |  | CPT | PPC |  | Readiness Assessment | 959.71 | 5.0 | PPC | Readiness Assessments | Green | GREEN | T2-RA-0800 | PSG | T2 |
| 2771 | 1.12.6 | **Readiness Assessments - Tier 1 Milestones** |  | 517d | 2025-06-24 | 2027-06-17 |  |  |  | 2025-06-24 | 2027-06-17 | 799d | 2023-11-17 | 2026-12-04 | 135d |  |  | N/A | N/A |  | Readiness Assessment |  | 5.0 | N/A | Readiness Assessments |  |  |  |  |  |
| 2772 | 1.12.6.1 | Readiness Assessment 6 - Start of Migration - Completed (incl. Readiness Assessment Report approval) | milestone | 0d | 2025-06-24 | 2025-06-24 | 2749 |  |  | 2025-06-24 | 2025-06-24 | 0d | 2025-04-04 | 2025-04-04 | 652d |  | finish no earlier than 2025-04-04 | CPT | PPC |  | Readiness Assessment | 236.71 | 5.0 | PPC | Readiness Assessments | Green | GREEN | T2-RA-0500 | PSG | T2 |
| 2773 | 1.12.6.2 | Readiness Assessment 7 - Migration Checkpoint - Completed (incl. Readiness Assessment Report approval) | milestone | 0d | 2026-03-19 | 2026-03-19 | 2756 |  |  | 2026-03-19 | 2026-03-19 | 0d | 2025-10-09 | 2025-10-09 | 460d |  |  | CPT | PPC |  | Readiness Assessment | 504.71 | 5.0 | PPC | Readiness Assessments | Green | GREEN | T2-RA-0600 | PSG | T2 |
| 2774 | 1.12.6.3 | Readiness Assessment 8 - Ready to Accept New MPANs - Completed (incl. Readiness Assessment Report approval) | milestone | 0d | 2026-10-13 | 2026-10-13 | 2763 |  |  | 2026-10-13 | 2026-10-13 | 0d | 2026-03-13 | 2026-03-13 | 312d |  |  | CPT | PPC |  | Readiness Assessment | 712.71 | 5.0 | PPC | Readiness Assessments | Green | GREEN | T2-RA-0700 | PSG | T2 |
| 2775 | 1.12.6.4 | Readiness Assessment 9 - Readiness for New Settlement Timetable - Completed (incl. Readiness Assessment Report approval) | milestone | 0d | 2027-06-17 | 2027-06-17 | 2770 |  |  | 2027-06-17 | 2027-06-17 | 0d | 2026-12-04 | 2026-12-04 | 135d |  |  | CPT | PPC |  | Readiness Assessment | 959.71 | 5.0 | PPC | Readiness Assessments | Green | GREEN | T2-RA-0800 | PSG | T2 |
| 2776 | 1.13 | **CONTROL POINTS** |  | 1204d | 2022-11-10 A | 2027-06-23 |  | 51% | 591.8d | 2022-11-10 | 2027-06-23 | 1063d | 2022-11-10 | 2026-12-07 | 132d |  |  | N/A | N/A |  | Control Points |  |  | N/A | Control Points |  |  |  |  |  |
| 2777 | 1.13.1 | **Control Point 1 - Start of System Design, Build & Test** |  | 20d | 2022-11-10 A | 2022-12-07 A |  | 100% |  | 2022-11-10 | 2022-12-07 | 20d | 2022-11-10 | 2022-12-07 |  |  |  | N/A | N/A |  | Control Points |  | 5.0 | N/A | Control Points |  |  |  |  |  |
| 2778 | 1.13.1.1 | Control Point 1 Preparation (incl. Control Point Report development and review) |  | 15d | 2022-11-10 A | 2022-11-30 A | 2779SS-20d | 100% |  | 2022-11-10 | 2022-11-30 | 15d | 2022-11-10 | 2022-11-30 |  |  |  | CPT | PMO |  | Control Points |  | 5.0 | PMO | Control Points | Complete | COMPLETE |  |  |  |
| 2779 | 1.13.1.2 | Control Point 1 - Start of System Design, Build & Test (incl. Control Point Report approval) | milestone | 0d | 2022-12-07 A | 2022-12-07 A |  | 100% |  | 2022-12-07 | 2022-12-07 | 0d | 2022-12-07 | 2022-12-07 |  |  | must finish on 2022-12-07 | CPT | PMO | D24 - CP2 Approval | Control Points |  | 5.0 | PMO | Control Points | Complete | COMPLETE | T1-CP-1000 | PSG | T1 |
| 2780 | 1.13.2 | **Control Point 2 - Start of Integration & Test** |  | 20d | 2023-10-02 A | 2023-10-30 A |  | 100% |  | 2023-10-02 | 2023-10-30 | 20d | 2023-10-02 | 2023-10-30 |  |  |  | N/A | N/A |  | Control Points |  | 5.0 | N/A | Control Points |  |  |  |  |  |
| 2781 | 1.13.2.1 | Control Point 2 Preparation (incl. Control Point Report development and review) |  | 15d | 2023-10-02 A | 2023-10-20 A | 2782SS-20d | 100% |  | 2023-10-02 | 2023-10-20 | 15d | 2023-10-02 | 2023-10-20 |  |  |  | CPT | PMO |  | Control Points |  | 5.0 | PMO | Control Points | Complete | COMPLETE |  |  |  |
| 2782 | 1.13.2.2 | Control Point 2 - Start of Integration & Test (incl. Control Point Report approval) | milestone | 0d | 2023-10-30 A | 2023-10-30 A | 1320 | 100% |  | 2023-10-30 | 2023-10-30 | 0d | 2023-10-30 | 2023-10-30 |  |  |  | CPT | PMO | D24 - CP2 Approval | Control Points |  | 5.11 | PMO | Control Points | Complete | COMPLETE | T1-CP-2000 | PSG | T1 |

| ID | WBS | Task | Type | Duration | Start | Finish | Predecessors | Complete | Remaining | Baseline start | Baseline finish | Baseline duration | Baseline 1 start | Baseline 1 finish | Total slack | Free slack | Responsible | Involved | Text3 | Text9 | Update Version | MHHS Resource Name | MHHS Programme Phase | Task Status | Sched Status | RAG | Milestone ID | Text29 | Tier |
| --- | --- | --- | --- | --- | --- | --- | --- | --- | --- | --- | --- | --- | --- | --- | --- | --- | --- | --- | --- | --- | --- | --- | --- | --- | --- | --- | --- | --- | --- |
| 2783 | 1.13.3 | **Control Point 3/4 - Readiness for Migration** |  | 20d | 2025-08-21 | 2025-09-18 |  |  |  | 2025-08-21 | 2025-09-18 | 20d | 2025-03-03 | 2025-03-28 | 591d |  | N/A | N/A | D26 - CP3 Approval | Control Points | 5.0 | N/A | Control Points |  |  |  |  |  |  |
| 2784 | 1.13.3.1 | Control Point 3/4 Preparation (incl. Control Point Report development and review) |  | 14d | 2025-08-21 | 2025-09-09 | 2785SS-20d |  |  | 2025-08-21 | 2025-09-09 | 14d | 2025-03-03 | 2025-03-21 | 597d |  | CPT | PMO |  | Control Points | 5.0 | PMO | Control Points | 294.33 | Green | GREEN |  |  |  |
| 2785 | 1.13.3.2 | Control Point 3/4 - Readiness for Migration (incl. Control Point Report approval) | milestone | 0d | 2025-09-18 | 2025-09-18 | 1588FS-5d |  |  | 2025-09-18 | 2025-09-18 | 0d | 2025-03-28 | 2025-03-28 | 591d | 0d | CPT | PMO |  | Control Points | 5.0 | PMO | Control Points | 322.33 | Green | GREEN | T1-CP-3000 | PSG | T1 |
| 2786 | 1.13.4 | **Control Point 5 - Cut Over to New Settlement Timetable** |  | 20d | 2027-05-26 | 2027-06-23 |  |  |  | 2027-05-26 | 2027-06-23 | 20d | 2026-11-10 | 2026-12-07 | 132d |  | N/A | N/A | D33 - Control Point 6 Approval | Control Points | 5.0 | N/A | Control Points | M16 |  |  |  |  |  |
| 2787 | 1.13.4.1 | Control Point 5 Preparation (incl. Control Point Report development and review) |  | 15d | 2027-05-26 | 2027-06-15 | 2788SS-20d |  |  | 2027-05-26 | 2027-06-15 | 15d | 2026-11-10 | 2026-11-30 | 137d |  | CPT | PP |  | Control Points | 5.0 | PMO | Control Points | 937.33 | Green | GREEN |  |  |  |
| 2788 | 1.13.4.2 | Control Point 5 - Cut Over to New Settlement Timetable (incl. Control Point Report approval) | milestone | 0d | 2027-06-23 | 2027-06-23 | 2692FS-8d |  |  | 2027-06-23 | 2027-06-23 | 0d | 2026-12-07 | 2026-12-07 | 132d | 0d | CPT | CPT | D33 - Control Point 6 Approval | Control Points | 5.0 | PMO | Control Points | 965.33 | Green | GREEN | T1-CP-4000 | PSG | T1 |
| 2789 | 1.13.5 | **Control Points - Tier 1 Milestones** |  | 1184d | 2022-12-07 A | 2027-06-23 |  |  | 1184d | 2022-12-07 | 2027-06-23 | 1043d | 2022-12-07 | 2026-12-07 | 132d |  | N/A | N/A |  | Control Points | 5.0 | N/A | Control Points |  |  |  |  |  |  |
| 2790 | 1.13.5.1 | Control Point 1 - Start of System Design, Build & Test (incl. Control Point Report approval) | milestone | 0d | 2022-12-07 A | 2022-12-07 A | 2779SS | 100% |  | 2022-12-07 | 2022-12-07 | 0d | 2022-12-07 | 2022-12-07 |  |  | CPT | PMO |  | Control Points | 5.0 | PMO | Control Points |  | Complete | COMPLETE | T1-CP-1000 | PSG | T1 |
| 2791 | 1.13.5.2 | Control Point 2 - Start of Integration & Test (incl. Control Point Report approval) | milestone | 0d | 2023-10-30 A | 2023-10-30 A | 2782SS | 100% |  | 2023-10-30 | 2023-10-30 | 0d | 2023-10-30 | 2023-10-30 |  |  | CPT | PMO | D24 - CP2 Approval | Control Points | 5.11 | PMO | Control Points |  | Complete | COMPLETE | T1-CP-2000 | PSG | T1 |
| 2792 | 1.13.5.3 | Control Point 3/4 - Readiness for Migration (incl. Control Point Report approval) | milestone | 0d | 2025-09-18 | 2025-09-18 | 2785SS |  |  | 2025-09-18 | 2025-09-18 | 0d | 2025-03-28 | 2025-03-28 | 591d |  | CPT | PMO |  | Control Points | 5.0 | PMO | Control Points | 322.33 | Green | GREEN | T1-CP-3000 | PSG | T1 |
| 2793 | 1.13.5.4 | Control Point 5 - Cut Over to New Settlement Timetable (incl. Control Point Report approval) | milestone | 0d | 2027-06-23 | 2027-06-23 | 2788SS |  |  | 2027-06-23 | 2027-06-23 | 0d | 2026-12-07 | 2026-12-07 | 132d |  | CPT | CPT | D33 - Control Point 6 Approval | Control Points | 5.0 | PMO | Control Points | 965.33 | Green | GREEN | T1-CP-4000 | PSG | T1 |
| 2794 | 1.14 | **MILESTONE RANGE CHECKPOINTS** |  | 1160d? | 2022-10-31 | 2027-04-12 |  |  |  | 2022-10-31 | 2027-04-12 | 436d | 2025-01-13 | 2026-09-15 | 184d |  | N/A | N/A |  | Milestone Range Checkpoints |  | N/A | Milestone Range Checkpoints |  |  |  |  |  |  |
| 2795 | 1.14.1 | **M10, M11, M12 and M13 milestone checkpoint** |  | 0d | 2025-07-31 | 2025-07-31 |  |  |  | 2025-07-31 | 2025-07-31 | 0d | 2025-01-13 | 2025-01-13 | 626d |  | N/A | N/A |  | Milestone Range Checkpoints | 5.0 | N/A | Milestone Range Checkpoints |  |  |  |  |  |  |
| 2796 | 1.14.1.1 | M10, M11, M12, and M13 milestone checkpoint - date approval | milestone | 0d | 2025-07-31 | 2025-07-31 | 2455FS-3mo, 2457FS-3mo, 2453FS-3mo, 1588FS-3mo |  |  | 2025-07-31 | 2025-07-31 | 0d | 2025-01-13 | 2025-01-13 | 626d |  | CPT | CPT |  | Milestone Range Checkpoints | 5.0 | PMO | Milestone Range Checkpoints | 273.33 | Green | GREEN | T2-MR-0100 | PSG | T2 |
| 2797 | 1.14.2 | **M14 milestone checkpoint** |  | 0d | 2026-08-06 | 2026-08-06 |  |  |  | 2026-08-06 | 2026-08-06 | 0d | 2025-12-23 | 2025-12-23 | 361d |  | N/A | N/A |  | Milestone Range Checkpoints | 5.0 | N/A | Milestone Range Checkpoints |  |  |  |  |  |  |
| 2798 | 1.14.2.1 | M14 milestone checkpoint - date approval | milestone | 0d | 2026-08-06 | 2026-08-06 | 2071FS-3mo |  |  | 2026-08-06 | 2026-08-06 | 0d | 2025-12-23 | 2025-12-23 | 361d |  | CPT | CPT |  | Milestone Range Checkpoints | 5.0 | PMO | Milestone Range Checkpoints | 644.33 | Green | GREEN | T2-MR-0200 | PSG | T2 |
| 2799 | 1.14.3 | **M15 milestone checkpoint** |  | 0d | 2027-02-15 | 2027-02-15 |  |  |  | 2027-02-15 | 2027-02-15 | 0d | 2026-07-14 | 2026-07-14 | 224d |  | N/A | N/A |  | Milestone Range Checkpoints | 5.0 | N/A | Milestone Range Checkpoints |  |  |  |  |  |  |
| 2800 | 1.14.3.1 | M15 milestone checkpoint - date approval | milestone | 0d | 2027-02-15 | 2027-02-15 | 2459FS-3mo |  |  | 2027-02-15 | 2027-02-15 | 0d | 2026-07-14 | 2026-07-14 | 224d |  | CPT | CPT |  | Milestone Range Checkpoints | 5.0 | PMO | Milestone Range Checkpoints | 837.33 | Green | GREEN | T2-MR-0300 | PSG | T2 |
| 2801 | 1.14.4 | **M16 milestone checkpoint** |  | 1160d? | 2022-10-31 | 2027-04-12 |  |  |  | 2022-10-31 | 2027-04-12 | 0d | 2026-09-15 | 2026-09-15 | 184d |  | N/A | N/A |  | Milestone Range Checkpoints | 5.0 | N/A | Milestone Range Checkpoints |  |  |  |  |  |  |
| 2802 | 1.14.4.1 | M16 milestone checkpoint - date approval | milestone | 0d | 2027-04-12 | 2027-04-12 | 2692FS-3mo |  |  | 2027-04-12 | 2027-04-12 | 0d | 2026-09-15 | 2026-09-15 | 184d |  | CPT | CPT |  | Milestone Range Checkpoints | 5.0 | PMO | Milestone Range Checkpoints | 893.33 | Green | GREEN | T2-MR-0400 | PSG | T2 |
