# Outline ELEXON Plan_kc

Schedule from MS Project, 2022-10-31 to 2027-12-23, status date 2024-10-21, A marks actual dates.

## Calendars

- Standard: Mon-Fri 08:00-12:00, 13:00-17:00; Sat-Sun off.

## Resources

| Resource |
| --- |
| PMO |
| SI |
| PPC |
| Lead Workstream |
| CPT |
| PP |
| SI Design |
| SI Design |
| SI Design |
| Design |
| SI DevOps |
| SI Test |
| PSG |
| DAG |
| TMAG |
| CCAG |
| Code drafters (SRO Design Team |
| Code Bodies) |
| CCAG PM |
| Programme Participants |
| Code drafters |
| CDWG |
| SRO Design Team |
| Code Bodies |
| Ofgem |
| Elexon resources TBC |
| LDP Programme Manager |
| SRO Client Programme Director |
| IPA |
| LDP |
| SRO |
| )) |
| ? |
| TBC |
| OOC |
| MHHSP |
| Adrian Page |
| Amy Clayton |
| Anand Kaveripatna |
| Berlinda Kugara |
| Cesar Lopes |
| Charlie Blanks |
| Chetan Ubale |
| Daniel Callender |
| Daniel Gee |
| David Hollinshead |
| Dean Bailey |
| Dominic Mooney |
| Elayaraja Jeyaraman |
| Georgi Rabotov |
| Giles Clayden |
| Helen Richardson |
| Ishti Bhatti |
| Jafer Shah |
| Jason Brogden |
| John Edmonds Bell |
| John Wiggins |
| Karthikeyan Ganesan |
| Kasimali Hajiyani |
| Kate Goodman |
| Keegan Moodley |
| Keith Clark |
| Keith Lawlor |
| kevin Davis |
| Kishore Konduru |
| Kyle Abraham |
| Mahjabeen Newaz |
| Martin Freeman |
| Matt Hall |
| Matthew Breen |
| Michael Inije |
| Michael Walton |
| Ming Li |
| Nathalia Revlien |
| Nick Sewell |
| Nigel Hunt |
| Oskar Cahill |
| Paul Pettitt |
| Rakhee Shah |
| Rebecca Farooq |
| Renu Rathor |
| Robert Short |
| Robert Topley |
| Saadia Sajjad |
| Sean Tuffy |
| Shaid Hussain |
| Sharmeen Shaikh |
| Simon Berry |
| Steve Bradford |
| Steve Weston |
| Taaran Suri |
| Waseem Mohammed |
| Zak Hussain |
| berli |
| SI Migration |
| v |
| Andrew Margan |
| Lee Cox |
| DIP SP |
| DIPS SP |
| DIPSP |
| Ian Smith |
| N/A |
| SIT Component Integration Testing 2 Preparation Complete (incl. approval of SI SIT Component Integration Test Readiness Report) |
| Nich |
| Nicola Farley |
| Warren Fulton |
| Richard Puddephatt |
| Matthew Bray |
| Programme |
| LDSOs |
| Ben Wickins |
| paul |
| LDSO |
| Simon chidwick |
| Stuart Scott |
| MHHS Programme |
| Claire Silk |
| Laura Kennedy |
| Rowan B |
| FD |
| MB |
| AM |
| Roger Robar |
| Laura Kennedy. |

## Schedule

| ID | WBS | Task | Type | Duration | Start | Finish | Complete | Remaining | Baseline start | Baseline finish | Baseline duration | Baseline 1 start | Baseline 1 finish | Total slack | Constraint | Baseline cost | Responsible | Involved | Update Version | MHHS Resource Name | Sched Status | RAG | Text9 | Task Status | Future RAG |
| --- | --- | --- | --- | --- | --- | --- | --- | --- | --- | --- | --- | --- | --- | --- | --- | --- | --- | --- | --- | --- | --- | --- | --- | --- | --- |
| 1 | 1 | **PROGRAMME PLAN.** |  | 1344d? | 2022-10-31 A | 2027-12-23 | 54% | 617.86d? | 2022-10-31 | 2027-12-23 | 1195d |  |  |  |  | -0 | N/A | N/A | 5.0 | N/A |  |  |  |  |  |
| 2 | 1.1 | MHHS Programme Start | milestone | 0d | 2022-10-31 A | 2022-10-31 A | 100% |  | 2022-10-31 | 2022-10-31 | 0d |  |  |  |  |  | N/A | N/A | 5.7 | N/A | Complete | COMPLETE |  |  |  |
| 3 | 1.2 | **PROGRAMME MANAGEMENT** |  | 1089d | 2022-10-31 A | 2026-12-31 | 44% | 609.27d | 2022-10-31 | 2026-12-31 | 1089d | 2022-10-31 | 2026-12-31 | 255d |  |  | N/A | N/A | 5.0 | N/A |  |  |  |  |  |
| 4 | 1.2.1 | **Programme Management** |  | 1089d | 2022-10-31 A | 2026-12-31 | 43% | 616d | 2022-10-31 | 2026-12-31 | 1089d | 2022-10-31 | 2026-12-31 | 255d |  |  | N/A | N/A | 5.0 | N/A |  |  | Programme Management | M10 |  |
| 5 | 1.2.1.1 | Sprint-based prioritisation planning and execution |  | 1089d | 2022-10-31 A | 2026-12-31 | 43% | 616d | 2022-10-31 | 2026-12-31 | 1089d | 2022-10-31 | 2026-12-31 | 255d | finish no earlier than 2026-12-31 |  | PMO | CPT | 5.0 | N/A | Green | GREEN | Programme Management |  |  |
| 6 | 1.2.1.2 | Programme governance secretariat |  | 1089d | 2022-10-31 A | 2026-12-31 | 43% | 616d | 2022-10-31 | 2026-12-31 | 1089d | 2022-10-31 | 2026-12-31 | 255d |  |  | PMO | CPT | 5.0 | N/A | Green | GREEN | Programme Management |  |  |
| 7 | 1.2.1.3 | RAID management and reporting |  | 1089d | 2022-10-31 A | 2026-12-31 | 43% | 616d | 2022-10-31 | 2026-12-31 | 1089d | 2022-10-31 | 2026-12-31 | 255d |  |  | PMO | CPT | 5.0 | N/A | Green | GREEN | Programme Management |  |  |
| 8 | 1.2.1.4 | Tracking against Programme outcomes and KPIs |  | 1089d | 2022-10-31 A | 2026-12-31 | 43% | 616d | 2022-10-31 | 2026-12-31 | 1089d | 2022-10-31 | 2026-12-31 | 255d |  |  | PMO | CPT | 5.0 | N/A | Green | GREEN | Programme Management |  |  |
| 9 | 1.2.1.5 | Change control and reporting |  | 1089d | 2022-10-31 A | 2026-12-31 | 43% | 616d | 2022-10-31 | 2026-12-31 | 1089d | 2022-10-31 | 2026-12-31 | 255d |  |  | PMO | CPT | 5.0 | N/A | Green | GREEN | Programme Management |  |  |
| 10 | 1.2.1.6 | Ongoing identification of lessons learned relating to the PMO and implementation of improvements |  | 1089d | 2022-10-31 A | 2026-12-31 | 43% | 616d | 2022-10-31 | 2026-12-31 | 1089d | 2022-10-31 | 2026-12-31 | 255d |  |  | PMO | CPT | 5.0 | N/A | Green | GREEN | Programme Management |  |  |
| 11 | 1.2.2 | **Programme Internal Assurance Reviews** |  | 1089d | 2022-10-31 A | 2026-12-31 | 43% | 616d | 2022-10-31 | 2026-12-31 | 1089d | 2022-10-31 | 2026-12-31 | 255d |  |  | N/A | N/A | 5.0 | N/A |  |  | Programme Management | M9 | D18A - Quarterly Assurance Report |
| 12 | 1.2.2.1 | Programme Internal Assurance Reviews |  | 1089d | 2022-10-31 A | 2026-12-31 | 43% | 616d | 2022-10-31 | 2026-12-31 | 1089d | 2022-10-31 | 2026-12-31 | 255d |  |  | CPT | PMO | 5.0 | N/A | Green | GREEN | Programme Management |  | D18A - Quarterly Assurance Report |
| 13 | 1.2.3 | **Engagement with PPs** |  | 1089d | 2022-10-31 A | 2026-12-31 | 43% | 615.89d | 2022-10-31 | 2026-12-31 | 1089d | 2022-10-31 | 2026-12-31 | 255d |  |  | N/A | N/A | 5.0 | N/A |  |  | Programme Management | M5,M6 |  |
| 14 | 1.2.3.1 | Ongoing PP liaison activities |  | 1089d | 2022-10-31 A | 2026-12-31 | 43% | 616d | 2022-10-31 | 2026-12-31 | 1089d | 2022-10-31 | 2026-12-31 | 255d |  |  | PPC | CPT | 5.0 | N/A | Green | GREEN | Programme Management |  |  |
| 15 | 1.2.3.2 | Milestone and Control Point objective setting |  | 1089d | 2022-10-31 A | 2026-12-31 | 43% | 616d | 2022-10-31 | 2026-12-31 | 1089d | 2022-10-31 | 2026-12-31 | 255d |  |  | PPC | CPT | 5.0 | N/A | Green | GREEN | Programme Management |  |  |
| 16 | 1.2.3.3 | Reporting |  | 1089d | 2022-10-31 A | 2026-12-31 | 43% | 616d | 2022-10-31 | 2026-12-31 | 1089d | 2022-10-31 | 2026-12-31 | 255d |  |  | PPC |  | 5.0 | N/A | Green | GREEN | Programme Management |  |  |
| 17 | 1.2.3.4 | **PP Engagement Events** |  | 1089d | 2022-10-31 A | 2026-12-31 | 43% | 616d | 2022-10-31 | 2026-12-31 | 1089d | 2022-10-31 | 2026-12-31 | 255d |  |  | N/A | N/A | 5.0 | N/A |  |  | Programme Management |  |  |
| 18 | 1.2.3.4.1 | Bilateral meetings |  | 1089d | 2022-10-31 A | 2026-12-31 | 43% | 616d | 2022-10-31 | 2026-12-31 | 1089d | 2022-10-31 | 2026-12-31 | 255d |  |  | PPC | CPT | 5.0 | N/A | Green | GREEN | Programme Management |  |  |
| 19 | 1.2.3.4.2 | Monthly webinars |  | 1089d | 2022-10-31 A | 2026-12-31 | 43% | 616d | 2022-10-31 | 2026-12-31 | 1089d | 2022-10-31 | 2026-12-31 | 255d |  |  | PPC | CPT | 5.0 | N/A | Green | GREEN | Programme Management |  |  |
| 20 | 1.2.3.4.3 | Open days |  | 1089d | 2022-10-31 A | 2026-12-31 | 43% | 616d | 2022-10-31 | 2026-12-31 | 1089d | 2022-10-31 | 2026-12-31 | 255d |  |  | PPC | CPT | 5.0 | N/A | Green | GREEN | Programme Management |  |  |
| 21 | 1.2.3.5 | **PP Communications** |  | 1088d | 2022-10-31 A | 2026-12-30 | 43% | 615d | 2022-10-31 | 2026-12-30 | 1088d | 2022-10-31 | 2026-12-30 | 256d |  |  | N/A | N/A | 5.0 | N/A |  |  | Programme Management |  |  |
| 22 | 1.2.3.5.1 | The Clock updates (weekly) |  | 1088d | 2022-10-31 A | 2026-12-30 | 43% | 615d | 2022-10-31 | 2026-12-30 | 1088d | 2022-10-31 | 2026-12-30 | 256d |  |  | PPC |  | 5.0 | N/A | Green | GREEN | Programme Management |  |  |
| 23 | 1.2.3.5.2 | Maintain and update content on public-facing Portal (and ongoing feedback reviews to identify and implement Portal improvements) |  | 1088d | 2022-10-31 A | 2026-12-30 | 43% | 615d | 2022-10-31 | 2026-12-30 | 1088d | 2022-10-31 | 2026-12-30 | 256d |  |  | PPC |  | 5.0 | N/A | Green | GREEN | Programme Management |  |  |
| 24 | 1.2.4 | **Code Change Support / Other Programme Alignment** |  | 1089d | 2022-10-31 A | 2026-12-31 | 43% | 616d | 2022-10-31 | 2026-12-31 | 1089d | 2022-10-31 | 2026-12-31 | 255d |  |  | N/A | N/A | 5.0 | N/A |  |  | Programme Management | M6 | D17 - Code Change Report & Recommendations |
| 25 | 1.2.4.1 | Support DCC/BEIS on SEC change |  | 1089d | 2022-10-31 A | 2026-12-31 | 43% | 616d | 2022-10-31 | 2026-12-31 | 1089d | 2022-10-31 | 2026-12-31 | 255d |  |  | CPT |  | 5.0 | N/A | Green | GREEN | Programme Management |  |  |
| 26 | 1.2.4.2 | Support on Smart Meters Act changes |  | 1089d | 2022-10-31 A | 2026-12-31 | 43% | 616d | 2022-10-31 | 2026-12-31 | 1089d | 2022-10-31 | 2026-12-31 | 255d |  |  | CPT |  | 5.0 | N/A | Green | GREEN | Programme Management |  |  |
| 27 | 1.2.4.3 | Support DCC/RECCo on CSS change |  | 1089d | 2022-10-31 A | 2026-12-31 | 43% | 616d | 2022-10-31 | 2026-12-31 | 1089d | 2022-10-31 | 2026-12-31 | 255d |  |  | CPT |  | 5.0 | N/A | Green | GREEN | Programme Management |  |  |
| 28 | 1.2.4.4 | Support Elexon on BSC change |  | 1089d | 2022-10-31 A | 2026-12-31 | 43% | 616d | 2022-10-31 | 2026-12-31 | 1089d | 2022-10-31 | 2026-12-31 | 255d |  |  | CPT |  | 5.0 | N/A | Green | GREEN | Programme Management |  |  |
| 29 | 1.2.4.5 | Support code change inside & outside CCIAG |  | 1089d | 2022-10-31 A | 2026-12-31 | 43% | 616d | 2022-10-31 | 2026-12-31 | 1089d | 2022-10-31 | 2026-12-31 | 255d |  |  | CPT |  | 5.0 | N/A | Green | GREEN | Programme Management |  |  |
| 30 | 1.2.4.6 | Support code change inside & outside CCAG |  | 1089d | 2022-10-31 A | 2026-12-31 | 43% | 616d | 2022-10-31 | 2026-12-31 | 1089d | 2022-10-31 | 2026-12-31 | 255d |  |  | CPT |  | 5.0 | N/A | Green | GREEN | Programme Management |  |  |

| ID | WBS | Task | Type | Duration | Start | Finish | Predecessors | Complete | Remaining | Baseline start | Baseline finish | Baseline duration | Baseline 1 start | Baseline 1 finish | Total slack | Constraint | Baseline cost | Responsible | Involved | Text9 | Task Status | Update Version | MHHS Resource Name | Sched Status | RAG | Future RAG | MHHS Programme Phase | Text29 | Artefact ID | Milestone ID | Tier |
| --- | --- | --- | --- | --- | --- | --- | --- | --- | --- | --- | --- | --- | --- | --- | --- | --- | --- | --- | --- | --- | --- | --- | --- | --- | --- | --- | --- | --- | --- | --- | --- |
| 31 | 1.2.5 | **Programme Replan Baseline** |  | 163d | 2022-10-31 A | 2023-06-14 A |  | 100% |  | 2022-10-31 | 2023-06-14 | 163d | 2022-10-31 | 2023-06-14 |  |  |  | N/A | N/A | Programme Management | M5+ | 5.0 | N/A |  |  |  |  |  |  |  |  |
| 32 | 1.2.5.1 | Round 3 consultation preparation |  | 32d | 2022-10-31 A | 2022-12-13 A |  | 100% |  | 2022-10-31 | 2022-12-13 | 32d | 2022-10-31 | 2022-12-13 |  |  |  | PMO | CPT | Programme Management |  | 5.0 | N/A | Complete | COMPLETE |  |  |  |  |  |  |
| 33 | 1.2.5.2 | PSG decision to launch Round 3 consultation | milestone | 0d | 2022-12-07 A | 2022-12-07 A | 32FS-5d | 100% |  | 2022-12-07 | 2022-12-07 | 0d | 2022-12-07 | 2022-12-07 |  |  |  | PMO | PPC | Programme Management |  | 5.0 | N/A | Complete | COMPLETE |  |  |  |  |  |  |
| 34 | 1.2.5.3 | Round 3 consultation (incl. walkthroughs and Q&A) |  | 35d | 2022-12-14 A | 2023-01-31 A | 33FS+5d | 100% |  | 2022-12-14 | 2023-01-31 | 35d | 2022-12-14 | 2023-01-31 |  |  |  | PP | PMO, PPC,IPA | Programme Management |  | 5.0 | N/A | Complete | COMPLETE |  |  |  |  |  |  |
| 35 | 1.2.5.4 | Review and uplift of foundational testing documents to align with replan approach |  | 92d | 2022-12-14 A | 2023-04-20 A | 34SS | 100% |  | 2022-12-14 | 2023-04-20 | 92d | 2022-12-14 | 2023-04-20 |  |  |  | SI Test | CPT | Programme Management |  | 5.0 | N/A | Complete | COMPLETE |  |  |  |  |  |  |
| 36 | 1.2.5.5 | Round 3 consultation responses analysis (incl. identification of SIT volunteers) |  | 10d | 2023-02-01 A | 2023-02-14 A | 34 | 100% |  | 2023-02-01 | 2023-02-14 | 10d | 2023-02-01 | 2023-02-14 |  |  |  | PMO | CPT | Programme Management |  | 5.0 | N/A | Complete | COMPLETE |  |  |  |  |  |  |
| 37 | 1.2.5.6 | Replan re-drafting and supporting artefact updates (incl. engagement with Ofgem) |  | 26d | 2023-02-15 A | 2023-03-22 A | 36 | 100% |  | 2023-02-15 | 2023-03-22 | 26d | 2023-02-15 | 2023-03-22 |  |  |  | PMO | CPT,IPA,Ofgem | Programme Management |  | 5.0 | N/A | Complete | COMPLETE |  |  |  |  |  |  |
| 38 | 1.2.5.7 | Draft Replan Change Request |  | 31d | 2023-02-15 A | 2023-03-29 A | 36 | 100% |  | 2023-02-15 | 2023-03-29 | 31d | 2023-02-15 | 2023-03-29 |  |  |  | PMO | CPT | Programme Management |  | 5.0 | N/A | Complete | COMPLETE |  |  |  |  |  |  |
| 39 | 1.2.5.8 | PSG decision to issue CR for industry impact assessment | milestone | 0d | 2023-04-05 A | 2023-04-05 A | 38FS+5d | 100% |  | 2023-04-05 | 2023-04-05 | 0d | 2023-04-05 | 2023-04-05 |  |  |  | PMO | CPT | Programme Management |  | 5.0 | N/A | Complete | COMPLETE |  |  |  |  |  |  |
| 40 | 1.2.5.9 | Industry impact assessment |  | 10d | 2023-04-06 A | 2023-04-19 A | 39 | 100% |  | 2023-04-06 | 2023-04-19 | 10d | 2023-04-06 | 2023-04-19 |  |  |  | PP | PMO,PPC | Programme Management |  | 5.0 | N/A | Complete | COMPLETE |  |  |  |  |  |  |
| 41 | 1.2.5.10 | Replan playbacks (to assist PPs in impact assessment) |  | 5d | 2023-04-11 A | 2023-04-17 A | 40SS+3d | 100% |  | 2023-04-11 | 2023-04-17 | 5d | 2023-04-11 | 2023-04-17 |  |  |  | CPT | PPC,PP | Programme Management |  | 5.0 | N/A | Complete | COMPLETE |  |  |  |  |  |  |
| 42 | 1.2.5.11 | Industry impact assessment responses analysis |  | 5d | 2023-04-20 A | 2023-04-26 A | 40 | 100% |  | 2023-04-20 | 2023-04-26 | 5d | 2023-04-20 | 2023-04-26 |  |  |  | PMO | CPT | Programme Management |  | 5.0 | N/A | Complete | COMPLETE |  |  |  |  |  |  |
| 43 | 1.2.5.12 | Extraordinary PSG decision to agree baseline recommendation | milestone | 0d | 2023-05-03 A | 2023-05-03 A | 42FS+5d | 100% |  | 2023-05-03 | 2023-05-03 | 0d | 2023-05-03 | 2023-05-03 |  |  |  | CPT | PMO,PP | Programme Management |  | 5.0 | N/A | Complete | COMPLETE |  |  |  |  |  |  |
| 44 | 1.2.5.13 | Programme Replan playbacks and drop-in sessions |  | 5d | 2023-06-08 A | 2023-06-14 A |  | 100% |  | 2023-06-08 | 2023-06-14 | 5d | 2023-06-08 | 2023-06-14 |  |  |  | PMO | PPC, PP | Programme Management |  | 5.0 | N/A | Complete | COMPLETE |  |  |  |  |  |  |
| 45 | 1.3 | **DESIGN, BUILD & TEST (PIT)** |  | 1221d? | 2022-10-31 A | 2027-07-05 |  | 79% | 256.92d? | 2022-10-31 | 2027-07-05 | 1101d | 2022-10-31 | 2027-01-18 | 123d |  | -0 | N/A | N/A | DBT |  |  | N/A |  |  | 1 May 2022 - 31 Jul 2023 | Design, Build & Test (PIT) | DAG |  |  |  |
| 46 | 1.3.1 | **Design Baseline & Enduring PP Support** |  | 1101d | 2022-10-31 A | 2027-01-18 |  | 71% | 319.69d | 2022-10-31 | 2027-01-18 | 1101d | 2022-10-31 | 2027-01-18 | 243d |  | -0 | N/A | N/A | DBT |  | 5.0 | N/A |  |  |  | Design, Build & Test (PIT) |  |  |  |  |
| 47 | 1.3.1.1 | Physical design baselined (M5) | milestone | 0d | 2022-10-31 A | 2022-10-31 A |  | 100% |  | 2022-10-31 | 2022-10-31 | 0d | 2022-10-31 | 2022-10-31 |  |  |  | SRO Design | SI Design,PP,IPA | DBT |  | 5.0 | Paul Pettitt | Complete | COMPLETE |  | Design, Build & Test (PIT) | PSG | MHHS-ART001 | T1-DB-1000 | T1 |
| 48 | 1.3.1.2 | **M5 Design Work-Off Plan Implementation & Approval** |  | 79d | 2022-10-31 A | 2023-02-16 A |  | 100% |  | 2022-10-31 | 2023-02-16 | 79d | 2022-10-31 | 2023-02-16 |  |  |  | N/A | N/A | DBT |  | 5.0 | N/A |  |  |  | Design, Build & Test (PIT) |  |  |  |  |
| 49 | 1.3.1.2.1 | Implementation of M5 design Work-Off Plan |  | 74d | 2022-10-31 A | 2023-02-09 A | 47 | 100% |  | 2022-10-31 | 2023-02-09 | 74d | 2022-10-31 | 2023-02-09 |  |  |  | SI Design | PP | DBT |  | 5.0 | Paul Pettitt | Complete | COMPLETE |  | Design, Build & Test (PIT) |  |  |  |  |
| 50 | 1.3.1.2.2 | M5 design Work-Off Plan completion approved | milestone | 0d | 2023-02-16 A | 2023-02-16 A | 49FS+5d | 100% |  | 2023-02-16 | 2023-02-16 | 0d | 2023-02-16 | 2023-02-16 |  |  |  | SI Design | PP | DBT |  | 5.0 | Paul Pettitt | Complete | COMPLETE |  | Design, Build & Test (PIT) | DAG |  | T3-DB-0014 | T3 |
| 51 | 1.3.1.3 | **Enduring PP Design Support** |  | 1089d | 2022-10-31 A | 2026-12-31 A |  | 100% |  | 2022-10-31 | 2026-12-31 | 1089d | 2022-10-31 | 2026-12-31 |  |  |  | N/A | N/A | DBT |  | 5.0 | N/A |  |  |  | Design, Build & Test (PIT) |  |  |  |  |
| 52 | 1.3.1.3.1 | Design playbacks and drop-in sessions |  | 45d | 2022-10-31 A | 2022-12-30 A | 47 | 100% |  | 2022-10-31 | 2022-12-30 | 45d | 2022-10-31 | 2022-12-30 |  |  |  | SI Design | PMO,PPC, SRO Design | DBT |  | 5.0 | Paul Pettitt | Complete | COMPLETE |  | Design, Build & Test (PIT) |  |  |  |  |
| 53 | 1.3.1.3.2 | Support participants on E2E MHHS Design |  | 1089d | 2022-10-31 A | 2026-12-31 A | 47 | 100% |  | 2022-10-31 | 2026-12-31 | 1089d | 2022-10-31 | 2026-12-31 |  |  |  | SI Design | PP | DBT |  | 5.0 | Paul Pettitt | Complete | COMPLETE |  | Design, Build & Test (PIT) |  |  |  |  |
| 54 | 1.3.1.3.3 | DIP Onboarding Support |  | 70d | 2022-11-14 A | 2023-02-17 A |  | 100% |  | 2022-11-14 | 2023-02-17 | 70d | 2022-11-14 | 2023-02-17 |  | must start on 2022-11-14 |  | SI Design | SRO Design | DBT |  | 5.0 | Paul Pettitt | Complete | COMPLETE |  | Design, Build & Test (PIT) |  |  |  |  |
| 55 | 1.3.1.3.4 | iServer Launch | milestone | 0d | 2023-02-16 A | 2023-02-16 A | 50 | 100% |  | 2023-02-16 | 2023-02-16 | 0d | 2023-02-16 | 2023-02-16 |  |  |  | SI Design | PP | DBT |  | 5.0 | Paul Pettitt | Complete | COMPLETE |  | Design, Build & Test (PIT) |  |  |  |  |

| ID | WBS | Task | Type | Duration | Start | Finish | Predecessors | Complete | Remaining | Baseline start | Baseline finish | Baseline duration | Baseline 1 start | Baseline 1 finish | Total slack | Constraint | Baseline cost | Responsible | Involved | Text9 | Update Version | MHHS Resource Name | MHHS Programme Phase | Sched Status | RAG | Milestone ID | Text29 | Tier |
| --- | --- | --- | --- | --- | --- | --- | --- | --- | --- | --- | --- | --- | --- | --- | --- | --- | --- | --- | --- | --- | --- | --- | --- | --- | --- | --- | --- | --- |
| 56 | 1.3.1.4 | **Establish Design Change Management Processes** |  | 1101d | 2022-10-31 A | 2027-01-18 |  | 36% | 706.22d | 2022-10-31 | 2027-01-18 | 1101d | 2022-10-31 | 2027-01-18 | 243d |  |  | N/A | N/A | DBT | 5.0 | N/A | Design, Build & Test (PIT) |  |  |  |  |  |
| 57 | 1.3.1.4.1 | Internal review of internal change management processes |  | 35d | 2022-10-31 A | 2022-12-16 A |  | 100% |  | 2022-10-31 | 2022-12-16 | 35d | 2022-10-31 | 2022-12-16 |  |  |  | SRO | SI Design | DBT | 5.0 | Paul Pettitt | Design, Build & Test (PIT) | Complete | COMPLETE |  |  |  |
| 58 | 1.3.1.4.2 | SRO approval of internal change management processes | milestone | 0d | 2022-12-16 A | 2022-12-16 A | 57FF | 100% |  | 2022-12-16 | 2022-12-16 | 0d | 2022-12-16 | 2022-12-16 |  |  |  | SRO | SI Design | DBT | 5.0 | Paul Pettitt | Design, Build & Test (PIT) | Complete | COMPLETE |  |  |  |
| 59 | 1.3.1.4.3 | Change Process Webinar | milestone | 0d | 2023-01-16 A | 2023-01-16 A |  | 100% |  | 2023-01-16 | 2023-01-16 | 0d | 2023-01-16 | 2023-01-16 |  | must start on 2023-01-16 |  | SI Design | PP | DBT | 5.0 | Paul Pettitt | Design, Build & Test (PIT) | Complete | COMPLETE |  |  |  |
| 60 | 1.3.1.4.4 | Enduring change management process approved | milestone | 0d | 2023-02-16 A | 2023-02-16 A | 50FF | 100% |  | 2023-02-16 | 2023-02-16 | 0d | 2023-02-16 | 2023-02-16 |  |  |  | SI Design | PP | DBT | 5.0 | Paul Pettitt | Design, Build & Test (PIT) | Complete | COMPLETE | T3-DB-0016 | DAG | T3 |
| 61 | 1.3.1.4.5 | Maintain E2E MHHS Design (post-M5 design change management processes operational) |  | 1022d | 2023-02-17 A | 2027-01-18 | 60 | 34% | 678d | 2023-02-17 | 2027-01-18 | 1022d | 2023-02-17 | 2027-01-18 | 243d |  |  | SI Design | PP | DBT | 5.0 | Paul Pettitt | Design, Build & Test (PIT) | Green | GREEN |  |  |  |
| 62 | 1.3.1.5 | **Design Authority Mobilisation** |  | 29d | 2022-12-14 A | 2023-01-23 A |  | 100% |  | 2022-12-14 | 2023-01-23 | 29d | 2022-12-14 | 2023-01-23 |  |  |  | N/A | N/A | DBT | 5.0 | N/A | Design, Build & Test (PIT) |  |  |  |  |  |
| 63 | 1.3.1.5.1 | Design Authority ToR approved | milestone | 0d | 2022-12-14 A | 2022-12-14 A |  | 100% |  | 2022-12-14 | 2022-12-14 | 0d | 2022-12-14 | 2022-12-14 |  | must start on 2022-12-14 |  | SI Design | PP | DBT | 5.0 | Paul Pettitt | Design, Build & Test (PIT) | Complete | COMPLETE | T3-DB-0010 | DAG | T3 |
| 64 | 1.3.1.5.2 | Inaugural Design Authority | milestone | 0d | 2023-01-23 A | 2023-01-23 A | 63FS+29d | 100% |  | 2023-01-23 | 2023-01-23 | 0d | 2023-01-23 | 2023-01-23 |  |  |  | SI Design | PP | DBT | 5.0 | Paul Pettitt | Design, Build & Test (PIT) | Complete | COMPLETE |  |  |  |
| 65 | 1.3.1.6 | **Network Operation Services Adaptor Procurement** |  | 0d | 2023-05-23 A | 2023-05-23 A |  | 100% |  | 2023-05-23 | 2023-05-23 | 0d | 2023-02-01 | 2025-03-14 |  |  | -0 | N/A | N/A | DBT | 5.0 | N/A | Design, Build & Test (PIT) |  |  |  |  |  |
| 66 | 1.3.1.6.1 | All SIT LDSOs have procured their adapter providers | milestone | 0d | 2023-05-23 A | 2023-05-23 A | 586SS | 100% |  | 2023-05-23 | 2023-05-23 | 0d | 2023-05-23 | 2023-05-23 |  |  |  | SI Design | PP | DBT | 5.0 | Paul Pettitt | Design, Build & Test (PIT) | Complete | COMPLETE | T3-DB-0020 | DAG | T3 |
| 67 | 1.3.2 | **PP Mobilisation** |  | 67d | 2022-10-31 A | 2023-01-31 A |  | 100% |  | 2022-10-31 | 2023-01-31 | 67d | 2022-10-31 | 2023-01-31 |  |  |  | N/A | N/A | DBT | 5.0 | N/A | Design, Build & Test (PIT) |  |  |  |  |  |
| 68 | 1.3.2.1 | Set up governance |  | 67d | 2022-10-31 A | 2023-01-31 A |  | 100% |  | 2022-10-31 | 2023-01-31 | 67d | 2022-10-31 | 2023-01-31 |  |  |  | PP |  | DBT | 5.0 | PP | Design, Build & Test (PIT) | Complete | COMPLETE |  |  |  |
| 69 | 1.3.2.2 | Set up reporting |  | 67d | 2022-10-31 A | 2023-01-31 A |  | 100% |  | 2022-10-31 | 2023-01-31 | 67d | 2022-10-31 | 2023-01-31 |  |  |  | PP |  | DBT | 5.0 | PP | Design, Build & Test (PIT) | Complete | COMPLETE |  |  |  |
| 70 | 1.3.2.3 | Obtain funding |  | 67d | 2022-10-31 A | 2023-01-31 A |  | 100% |  | 2022-10-31 | 2023-01-31 | 67d | 2022-10-31 | 2023-01-31 |  |  |  | PP |  | DBT | 5.0 | PP | Design, Build & Test (PIT) | Complete | COMPLETE |  |  |  |
| 71 | 1.3.2.4 | Earmark resources |  | 67d | 2022-10-31 A | 2023-01-31 A |  | 100% |  | 2022-10-31 | 2023-01-31 | 67d | 2022-10-31 | 2023-01-31 |  |  |  | PP |  | DBT | 5.0 | PP | Design, Build & Test (PIT) | Complete | COMPLETE |  |  |  |
| 72 | 1.3.2.5 | Mobilise initial team |  | 67d | 2022-10-31 A | 2023-01-31 A |  | 100% |  | 2022-10-31 | 2023-01-31 | 67d | 2022-10-31 | 2023-01-31 |  |  |  | PP |  | DBT | 5.0 | PP | Design, Build & Test (PIT) | Complete | COMPLETE |  |  |  |
| 73 | 1.3.3 | **PIT Stub Specification and Delivery** |  | 435d | 2022-10-31 A | 2024-06-28 A |  | 100% |  | 2022-10-31 | 2024-06-28 | 430d | 2022-10-31 | 2023-05-31 |  |  | -0 | N/A | N/A | DBT | 5.0 | N/A | Design, Build & Test (PIT) |  |  |  |  |  |
| 74 | 1.3.3.1 | **DIP Simulator** |  | 108d | 2022-10-31 A | 2023-03-29 A |  | 100% |  | 2022-10-31 | 2023-03-29 | 108d | 2022-10-31 | 2023-03-29 |  |  |  | N/A | N/A | DBT | 5.0 | N/A | Design, Build & Test (PIT) |  |  |  |  |  |
| 75 | 1.3.3.1.1 | Build & Test |  | 95d | 2022-10-31 A | 2023-03-10 A | 47 | 100% |  | 2022-10-31 | 2023-03-10 | 95d | 2022-10-31 | 2023-03-10 |  |  |  | SI DevOps |  | DBT | 5.0 | Rebecca Farooq | Design, Build & Test (PIT) | Complete | COMPLETE |  |  |  |
| 76 | 1.3.3.1.2 | UAT |  | 85d | 2022-11-14 A | 2023-03-10 A | 75SS+10d | 100% |  | 2022-11-14 | 2023-03-10 | 85d | 2022-11-14 | 2023-03-10 |  |  |  | SI Test |  | DBT | 5.0 | Rebecca Farooq | Design, Build & Test (PIT) | Complete | COMPLETE |  |  |  |
| 77 | 1.3.3.1.3 | Beta test |  | 95d | 2022-10-31 A | 2023-03-10 A | 75SS | 100% |  | 2022-10-31 | 2023-03-10 | 95d | 2022-10-31 | 2023-03-10 |  |  |  | PP | SI Test | DBT | 5.0 | Rebecca Farooq | Design, Build & Test (PIT) | Complete | COMPLETE |  |  |  |
| 78 | 1.3.3.1.4 | Prepare for release |  | 18d | 2023-03-06 A | 2023-03-29 A | 77FS-5d | 100% |  | 2023-03-06 | 2023-03-29 | 18d | 2023-03-06 | 2023-03-29 |  |  |  | SI DevOps |  | DBT | 5.0 | Rebecca Farooq | Design, Build & Test (PIT) | Complete | COMPLETE |  |  |  |
| 79 | 1.3.3.1.5 | DIP Simulator released | milestone | 0d | 2023-03-29 A | 2023-03-29 A | 78FF | 100% |  | 2023-03-29 | 2023-03-29 | 0d | 2023-03-29 | 2023-03-29 |  | start no earlier than 2023-01-30 |  | SI DevOps |  | DBT | 5.0 | Rebecca Farooq | Design, Build & Test (PIT) | Complete | COMPLETE | T3-DB-0018 | SITAG | T3 |

| ID | WBS | Task | Type | Duration | Start | Finish | Predecessors | Complete | Remaining | Baseline start | Baseline finish | Baseline duration | Baseline 1 start | Baseline 1 finish | Total slack | Constraint | Baseline cost | Responsible | Involved | Text9 | Update Version | MHHS Resource Name | MHHS Programme Phase | Sched Status | RAG | Milestone ID | Text29 | Tier |
| --- | --- | --- | --- | --- | --- | --- | --- | --- | --- | --- | --- | --- | --- | --- | --- | --- | --- | --- | --- | --- | --- | --- | --- | --- | --- | --- | --- | --- |
| 80 | 1.3.3.2 | **DIP Simulator Uplifts** |  | 257d | 2023-07-06 A | 2024-06-28 A |  | 100% |  | 2023-07-06 | 2024-06-28 | 252d |  |  |  |  | -0 | N/A | N/A | DBT | 5.1 | N/A | Design, Build & Test (PIT) |  |  |  |  |  |
| 81 | 1.3.3.2.1 | DIP Simulator uplifted to align with design releases - design/build/test |  | 27d | 2023-07-06 A | 2023-08-11 A | 117 | 100% |  | 2023-07-06 | 2023-08-11 | 27d |  |  |  |  |  | SI DevOps |  | DBT | 5.1 | Rebecca Farooq | Design, Build & Test (PIT) | Complete | COMPLETE |  |  |  |
| 82 | 1.3.3.2.2 | DIP Simulator uplifted to align with Interim Release 2 | milestone | 0d | 2023-08-11 A | 2023-08-11 A | 81 | 100% |  | 2023-08-11 | 2023-08-11 | 0d |  |  |  |  |  | SI DevOps |  | DBT | 5.1 | Rebecca Farooq | Design, Build & Test (PIT) | Complete | COMPLETE | T3-DB-0035 | SITAG | T3 |
| 83 | 1.3.3.2.3 | DIP Simulator uplifted to align with design releases - design/build/test |  | 20d | 2023-10-09 A | 2023-11-03 A | 126FS+2d | 100% |  | 2023-10-09 | 2023-11-03 | 20d |  |  |  |  |  | SI DevOps |  | DBT | 5.3 | Rebecca Farooq | Design, Build & Test (PIT) | Complete | COMPLETE |  |  |  |
| 84 | 1.3.3.2.4 | DIP Simulator uplifted to align with Interim Release 5 | milestone | 0d | 2023-11-03 A | 2023-11-03 A | 83 | 100% |  | 2023-11-03 | 2023-11-03 | 0d |  |  |  |  |  | SI DevOps |  | DBT | 5.11 | Rebecca Farooq | Design, Build & Test (PIT) | Complete | COMPLETE | T3-DB-0039 | SITAG | T3 |
| 85 | 1.3.3.2.5 | DIP Simulator uplifted to align with design releases - design/build/test |  | 37d | 2024-02-01 A | 2024-03-22 A | 134 | 100% |  | 2024-02-01 | 2024-03-22 | 37d |  |  |  |  |  | SI DevOps | PP,SRO,Testing | DBT | 5.14 | Matthew Bray | Design, Build & Test (PIT) | Complete | COMPLETE |  |  |  |
| 86 | 1.3.3.2.6 | DIP Simulator uplifted to align with Interim Release 7 | milestone | 0d | 2024-03-22 A | 2024-03-22 A | 85 | 100% |  | 2024-03-22 | 2024-03-22 | 0d |  |  |  |  |  | SI DevOps | PP,SRO,Testing | DBT | 5.14 | Matthew Bray | Design, Build & Test (PIT) | Complete | COMPLETE | T3-DB-0182 | SITAG | T3 |
| 87 | 1.3.3.2.7 | DIP Simulator uplifted to align with design releases - design/build/test |  | 57d | 2024-04-04 A | 2024-06-21 A | 138 | 100% |  | 2024-04-04 | 2024-06-21 | 57d |  |  |  |  |  | SI DevOps | PP,SRO,Testing | DBT | 5.14 | Matthew Bray | Design, Build & Test (PIT) | Complete | COMPLETE |  |  |  |
| 88 | 1.3.3.2.8 | DIP Simulator uplifted to align with Interim Release 8 | milestone | 0d | 2024-06-28 A | 2024-06-28 A | 87FS+5d | 100% |  | 2024-06-28 | 2024-06-28 | 0d |  |  |  |  |  | SI DevOps | PP,SRO,Testing | DBT | 5.28 | Matthew Bray | Design, Build & Test (PIT) | Complete | COMPLETE | T3-DB-0183 | SITAG | T3 |
| 89 | 1.3.3.3 | **Data Generator** |  | 130d | 2022-12-01 A | 2023-05-31 A |  | 100% |  | 2022-12-01 | 2023-05-31 | 130d | 2022-12-01 | 2023-05-31 |  |  |  | N/A | N/A | DBT | 5.0 | N/A | Design, Build & Test (PIT) |  |  |  |  |  |
| 90 | 1.3.3.3.1 | Design | manual | 15d | 2022-12-01 A | 2022-12-21 A |  | 100% |  | 2022-12-01 | 2022-12-21 | 15d | 2022-12-01 | 2022-12-21 |  |  |  | SI DevOps |  | DBT | 5.0 | Rebecca Farooq | Design, Build & Test (PIT) | Complete | COMPLETE |  |  |  |
| 91 | 1.3.3.3.2 | Build & Test |  | 50d | 2023-02-16 A | 2023-04-26 A | 90FS+40d | 100% |  | 2023-02-16 | 2023-04-26 | 50d | 2023-02-16 | 2023-04-26 |  |  |  | SI DevOps |  | DBT | 5.0 | Rebecca Farooq | Design, Build & Test (PIT) | Complete | COMPLETE |  |  |  |
| 92 | 1.3.3.3.3 | UAT |  | 10d | 2023-04-27 A | 2023-05-10 A | 91 | 100% |  | 2023-04-27 | 2023-05-10 | 10d | 2023-04-27 | 2023-05-10 |  |  |  | SI Test |  | DBT | 5.0 | Rebecca Farooq | Design, Build & Test (PIT) | Complete | COMPLETE |  |  |  |
| 93 | 1.3.3.3.4 | Beta test |  | 45d | 2023-03-30 A | 2023-05-31 A | 91FS-20d, 95FF | 100% |  | 2023-03-30 | 2023-05-31 | 45d | 2023-03-30 | 2023-05-31 |  |  |  | PP | SI Test | DBT | 5.0 | Rebecca Farooq | Design, Build & Test (PIT) | Complete | COMPLETE |  |  |  |
| 94 | 1.3.3.3.5 | Prepare for release |  | 24d | 2023-04-27 A | 2023-05-30 A | 92SS | 100% |  | 2023-04-27 | 2023-05-30 | 24d | 2023-04-27 | 2023-05-30 |  |  |  | SI DevOps |  | DBT | 5.0 | Rebecca Farooq | Design, Build & Test (PIT) | Complete | COMPLETE |  |  |  |
| 95 | 1.3.3.3.6 | Data Generator released | milestone | 0d | 2023-05-31 A | 2023-05-31 A | 94FS+1d | 100% |  | 2023-05-31 | 2023-05-31 | 0d | 2023-05-31 | 2023-05-31 |  |  |  | SI DevOps |  | DBT | 5.0 | Rebecca Farooq | Design, Build & Test (PIT) | Complete | COMPLETE | T3-DB-0022 | SITAG | T3 |
| 96 | 1.3.4 | **Design Artefact Releases** |  | 498d | 2023-02-22 A | 2025-01-17 |  | 98% | 11.58d | 2023-02-22 | 2024-11-13 | 398d | 2023-02-22 | 2023-09-29 | 764d |  | -0 | N/A | N/A | DBT | 5.0 | N/A | Design, Build & Test (PIT) |  |  |  | DAG |  |
| 97 | 1.3.4.1 | **Interim release 1** |  | 79d | 2023-02-22 A | 2023-06-12 A |  | 100% |  | 2023-02-22 | 2023-06-12 | 79d | 2023-02-22 | 2023-06-28 |  |  |  | N/A | N/A | DBT | 5.0 | N/A | Design, Build & Test (PIT) |  |  |  |  |  |
| 98 | 1.3.4.1.1 | Prioritise DINs and CR |  | 1d | 2023-02-22 A | 2023-02-22 A |  | 100% |  | 2023-02-22 | 2023-02-22 | 1d | 2023-02-22 | 2023-02-22 |  | must start on 2023-02-22 |  | SI Design |  | DBT | 5.0 | Paul Pettitt | Design, Build & Test (PIT) | Complete | COMPLETE |  |  |  |
| 99 | 1.3.4.1.2 | **Industry input session** |  | 7d | 2023-02-23 A | 2023-03-03 A |  | 100% |  | 2023-02-23 | 2023-03-03 | 7d | 2023-02-23 | 2023-03-03 |  |  |  | N/A | N/A | DBT | 5.0 | N/A | Design, Build & Test (PIT) |  |  |  |  |  |
| 100 | 1.3.4.1.2.1 | Raise a CR covering prioritized assessment cluster |  | 1d | 2023-02-23 A | 2023-02-23 A | 98 | 100% |  | 2023-02-23 | 2023-02-23 | 1d | 2023-02-23 | 2023-02-23 |  |  |  | SI Design |  | DBT | 5.0 | Paul Pettitt | Design, Build & Test (PIT) | Complete | COMPLETE |  |  |  |
| 101 | 1.3.4.1.2.2 | Organize Industry Input session to go through significant items to reach consensus |  | 1d | 2023-02-23 A | 2023-02-23 A | 100SS | 100% |  | 2023-02-23 | 2023-02-23 | 1d | 2023-02-23 | 2023-02-23 |  |  |  | SI Design | PP | DBT | 5.0 | Paul Pettitt,Berlinda Kugara | Design, Build & Test (PIT) | Complete | COMPLETE |  |  |  |
| 102 | 1.3.4.1.2.3 | Conduct Meeting |  | 1d | 2023-03-03 A | 2023-03-03 A | 101FS+5d | 100% |  | 2023-03-03 | 2023-03-03 | 1d | 2023-03-03 | 2023-03-03 |  |  |  | SI Design | PP | DBT | 5.0 | Paul Pettitt,Berlinda Kugara | Design, Build & Test (PIT) | Complete | COMPLETE |  |  |  |
| 103 | 1.3.4.1.3 | Update baselined artefacts |  | 10d | 2023-03-24 A | 2023-04-06 A |  | 100% |  | 2023-03-24 | 2023-04-06 | 10d | 2023-03-24 | 2023-04-06 |  |  |  | SI Design |  | DBT | 5.0 | Paul Pettitt | Design, Build & Test (PIT) | Complete | COMPLETE |  |  |  |

Notes:
- 84: Action: 26/7/23 - forecast changed from 15/12/23 - 3/11/23 - Changed from Interim Release 6 to 5. Updated in milestone register

| ID | WBS | Task | Type | Duration | Start | Finish | Predecessors | Complete | Baseline start | Baseline finish | Baseline duration | Baseline 1 start | Baseline 1 finish | Constraint | Baseline cost | Responsible | Involved | Text9 | Update Version | MHHS Resource Name | MHHS Programme Phase | Sched Status | RAG | Milestone ID | Text29 | Tier | Action |
| --- | --- | --- | --- | --- | --- | --- | --- | --- | --- | --- | --- | --- | --- | --- | --- | --- | --- | --- | --- | --- | --- | --- | --- | --- | --- | --- | --- |
| 104 | 1.3.4.1.4 | **Participant review and impact assess changes** |  | 18d | 2023-04-14 A | 2023-05-09 A |  | 100% | 2023-04-14 | 2023-05-09 | 18d | 2023-04-14 | 2023-05-09 |  |  | N/A | N/A | DBT | 5.0 | N/A | Design, Build & Test (PIT) |  |  |  |  |  |  |
| 105 | 1.3.4.1.4.1 | Issue Redline Version of documents |  | 1d | 2023-04-14 A | 2023-04-14 A | 103FS+5d | 100% | 2023-04-14 | 2023-04-14 | 1d | 2023-04-14 | 2023-04-14 |  |  | SI Design |  | DBT | 5.0 | Paul Pettitt | Design, Build & Test (PIT) | Complete | COMPLETE |  |  |  |  |
| 106 | 1.3.4.1.4.2 | Participants provide review comments to common log |  | 17d | 2023-04-17 A | 2023-05-09 A | 105 | 100% | 2023-04-17 | 2023-05-09 | 17d | 2023-04-17 | 2023-05-09 |  |  | PP |  | DBT | 5.0 | Paul Pettitt | Design, Build & Test (PIT) | Complete | COMPLETE |  |  |  |  |
| 107 | 1.3.4.1.5 | **Assurance review** |  | 19d | 2023-05-10 A | 2023-06-05 A |  | 100% | 2023-05-10 | 2023-06-05 | 19d | 2023-05-10 | 2023-06-05 |  |  | N/A | N/A | DBT | 5.0 | N/A | Design, Build & Test (PIT) |  |  |  |  |  |  |
| 108 | 1.3.4.1.5.1 | SI Design Review and Respond to Comments |  | 5d | 2023-05-10 A | 2023-05-16 A | 106 | 100% | 2023-05-10 | 2023-05-16 | 5d | 2023-05-10 | 2023-05-16 |  |  | SI Design |  | DBT | 5.0 | Paul Pettitt | Design, Build & Test (PIT) | Complete | COMPLETE |  |  |  |  |
| 109 | 1.3.4.1.5.2 | Prep for Assurance Review Meeting |  | 7d | 2023-05-17 A | 2023-05-25 A | 108 | 100% | 2023-05-17 | 2023-05-25 | 7d | 2023-05-17 | 2023-05-25 |  |  | SI Design |  | DBT | 5.0 | Paul Pettitt | Design, Build & Test (PIT) | Complete | COMPLETE |  |  |  |  |
| 110 | 1.3.4.1.5.3 | Conduct Assurance Review Meeting |  | 1d | 2023-05-26 A | 2023-05-26 A | 109 | 100% | 2023-05-26 | 2023-05-26 | 1d | 2023-05-26 | 2023-05-26 |  |  | SI Design |  | DBT | 5.0 | Paul Pettitt | Design, Build & Test (PIT) | Complete | COMPLETE |  |  |  |  |
| 111 | 1.3.4.1.5.4 | Update Artefacts following Assurance Review |  | 6d | 2023-05-29 A | 2023-06-05 A | 110 | 100% | 2023-05-29 | 2023-06-05 | 6d | 2023-05-29 | 2023-06-05 |  |  | SI Design |  | DBT | 5.0 | Paul Pettitt | Design, Build & Test (PIT) | Complete | COMPLETE |  |  |  |  |
| 112 | 1.3.4.1.6 | PSG Approval of interim release plan |  | 1d | 2023-06-08 A | 2023-06-08 A |  | 100% | 2023-06-08 | 2023-06-08 | 1d |  |  | must start on 2023-06-08 |  | PP | SI Design | DBT | 5.1 | Paul Pettitt | Design, Build & Test (PIT) | Complete | COMPLETE |  |  |  |  |
| 113 | 1.3.4.1.7 | Publish updated baselined artefacts | milestone | 0d | 2023-06-06 A | 2023-06-12 A | 111 | 100% | 2023-06-06 | 2023-06-12 | 5d | 2023-06-15 | 2023-06-21 |  |  | SI Design |  | DBT | 5.0 | Paul Pettitt | Design, Build & Test (PIT) | Complete | COMPLETE |  |  |  |  |
| 114 | 1.3.4.1.8 | Interim release 1 Go live | milestone | 0d | 2023-06-12 A | 2023-06-12 A | 113 | 100% | 2023-06-12 | 2023-06-12 | 0d | 2023-06-28 | 2023-06-28 |  |  | SI Design |  | DBT | 5.0 | Paul Pettitt | Design, Build & Test (PIT) | Complete | COMPLETE | T3-DB-0095 | DAG | T3 |  |
| 115 | 1.3.4.2 | **Interim release 2** |  | 27d | 2023-05-30 A | 2023-07-05 A |  | 100% | 2023-05-30 | 2023-07-05 | 27d | 2023-05-24 | 2023-07-28 |  |  | N/A | N/A | DBT | 5.0 | N/A | Design, Build & Test (PIT) |  |  |  |  |  |  |
| 116 | 1.3.4.2.1 | Update baselined artefacts |  | 27d | 2023-05-30 A | 2023-07-05 A |  | 100% | 2023-05-30 | 2023-07-05 | 27d |  |  | must start on 2023-05-30 |  | SI Design | PP | DBT | 5.1 | Paul Pettitt | Design, Build & Test (PIT) | Complete | COMPLETE |  |  |  |  |
| 117 | 1.3.4.2.2 | Interim release 2 Go live | milestone | 0d | 2023-07-05 A | 2023-07-05 A | 116 | 100% | 2023-07-05 | 2023-07-05 | 0d | 2023-07-28 | 2023-07-28 |  |  | SI Design |  | DBT | 5.0 | Paul Pettitt | Design, Build & Test (PIT) | Complete | COMPLETE | T3-DB-0096 | DAG | T3 |  |
| 118 | 1.3.4.3 | **Interim release 3** |  | 35d | 2023-06-15 A | 2023-08-02 A |  | 100% | 2023-06-15 | 2023-08-02 | 35d | 2023-06-29 | 2023-09-29 |  |  | N/A | N/A | DBT | 5.0 | N/A | Design, Build & Test (PIT) |  |  |  |  |  |  |
| 119 | 1.3.4.3.1 | Update baselined artefacts |  | 35d | 2023-06-15 A | 2023-08-02 A |  | 100% | 2023-06-15 | 2023-08-02 | 35d |  |  | must start on 2023-06-15 |  | SI Design | PP | DBT | 5.1 | Paul Pettitt | Design, Build & Test (PIT) | Complete | COMPLETE |  |  |  |  |
| 120 | 1.3.4.3.2 | Interim release 3 Go live | milestone | 0d | 2023-08-02 A | 2023-08-02 A | 119 | 100% | 2023-08-02 | 2023-08-02 | 0d | 2023-09-29 | 2023-09-29 |  |  | SI Design |  | DBT | 5.0 | Paul Pettitt | Design, Build & Test (PIT) | Complete | COMPLETE | T3-DB-0097 | DAG | T3 |  |
| 121 | 1.3.4.4 | **Interim release 4** |  | 36d | 2023-07-12 A | 2023-08-30 A |  | 100% | 2023-07-12 | 2023-08-30 | 36d |  |  |  |  | N/A | N/A | DBT | 5.1 | N/A | Design, Build & Test (PIT) |  |  |  |  |  |  |
| 122 | 1.3.4.4.1 | Update baselined artefacts |  | 36d | 2023-07-12 A | 2023-08-30 A |  | 100% | 2023-07-12 | 2023-08-30 | 36d |  |  | must start on 2023-07-12 |  | SI Design | PP | DBT | 5.1 | Paul Pettitt | Design, Build & Test (PIT) | Complete | COMPLETE |  |  |  |  |
| 123 | 1.3.4.4.2 | Interim release 4 Go live | milestone | 0d | 2023-08-30 A | 2023-08-30 A | 122 | 100% | 2023-08-30 | 2023-08-30 | 0d |  |  |  |  | SI Design |  | DBT | 5.1 | Paul Pettitt | Design, Build & Test (PIT) | Complete | COMPLETE | T3-DB-0081 | DAG | T3 |  |
| 124 | 1.3.4.5 | **Interim release 5** |  | 147d | 2023-08-17 A | 2024-03-08 A |  | 100% | 2023-08-17 | 2024-03-08 | 147d |  |  |  | -0 | N/A | N/A | DBT | 5.1 | N/A | Design, Build & Test (PIT) |  |  |  |  |  |  |
| 125 | 1.3.4.5.1 | Update baselined artefacts |  | 35d | 2023-08-17 A | 2023-10-04 A |  | 100% | 2023-08-17 | 2023-10-04 | 35d |  |  | must start on 2023-08-17 |  | SI Design | PP | DBT | 5.1 | Paul Pettitt | Design, Build & Test (PIT) | Complete | COMPLETE |  |  |  |  |
| 126 | 1.3.4.5.2 | Interim release 5 Go live | milestone | 0d | 2023-10-04 A | 2023-10-04 A | 125 | 100% | 2023-10-04 | 2023-10-04 | 0d |  |  |  |  | SI Design |  | DBT | 5.1 | Paul Pettitt | Design, Build & Test (PIT) | Complete | COMPLETE | T3-DB-0083 | DAG | T3 | 11/8 - successor is SIT functional (starts in march) |
| 127 | 1.3.4.5.3 | Interim Release 5 Deployed to SIT |  | 10d | 2024-02-26 A | 2024-03-08 A | 126FS+102d | 100% | 2024-02-26 | 2024-03-08 | 10d |  |  |  |  | SI Testing | PP | DBT | 5.16 |  |  | Complete | COMPLETE |  |  |  |  |

| ID | WBS | Task | Type | Duration | Start | Finish | Predecessors | Complete | Remaining | Baseline start | Baseline finish | Baseline duration | Baseline 1 start | Baseline 1 finish | Total slack | Constraint | Baseline cost | Responsible | Involved | Text9 | Update Version | MHHS Resource Name | MHHS Programme Phase | Sched Status | RAG | Milestone ID | Text29 | Tier | Action | Task Status |
| --- | --- | --- | --- | --- | --- | --- | --- | --- | --- | --- | --- | --- | --- | --- | --- | --- | --- | --- | --- | --- | --- | --- | --- | --- | --- | --- | --- | --- | --- | --- |
| 128 | 1.3.4.6 | **Interim release 6** |  | 192d | 2023-09-14 A | 2024-06-07 A |  | 100% |  | 2023-09-14 | 2024-06-07 | 192d |  |  |  |  | -0 | N/A | N/A | DBT | 5.1 | N/A | Design, Build & Test (PIT) |  |  |  |  |  |  |  |
| 129 | 1.3.4.6.1 | Update baselined artefacts |  | 35d | 2023-09-14 A | 2023-11-01 A |  | 100% |  | 2023-09-14 | 2023-11-01 | 32d |  |  |  | must start on 2023-09-14 |  | SI Design | PP | DBT | 5.1 | Paul Pettitt | Design, Build & Test (PIT) | Complete | COMPLETE |  |  |  |  |  |
| 130 | 1.3.4.6.2 | Interim release 6 Go live | milestone | 0d | 2023-11-01 A | 2023-11-01 A | 129 | 100% |  | 2023-11-01 | 2023-11-01 | 0d |  |  |  |  |  | SI Design |  | DBT | 5.11 | Paul Pettitt | Design, Build & Test (PIT) | Complete | COMPLETE | T3-DB-0085 | DAG | T3 |  |  |
| 131 | 1.3.4.6.3 | Interim Release 6 Deployed to SIT |  | 10d | 2024-05-27 A | 2024-06-07 A | 130FS+147d | 100% |  | 2024-05-27 | 2024-06-07 | 10d |  |  |  |  |  | SI Testing | PP | DBT | 5.16 |  |  | Complete | COMPLETE |  |  |  |  |  |
| 132 | 1.3.4.7 | **Interim release 7** |  | 168d | 2023-10-18 A | 2024-06-07 A |  | 100% |  | 2023-10-18 | 2024-06-07 | 168d |  |  |  |  | -0 | N/A | N/A | DBT | 5.5 | N/A | Design, Build & Test (PIT) |  |  |  |  |  |  |  |
| 133 | 1.3.4.7.1 | Update baselined artefacts |  | 76d | 2023-10-18 A | 2024-01-31 A |  | 100% |  | 2023-10-18 | 2024-01-31 | 76d |  |  |  | start no earlier than 2023-10-18 |  | SI Design | PP | DBT | 5.5 | Paul Pettitt | Design, Build & Test (PIT) | Complete | COMPLETE |  |  |  |  |  |
| 134 | 1.3.4.7.2 | Interim release 7 Go live | milestone | 0d | 2024-01-31 A | 2024-01-31 A | 133 | 100% |  | 2024-01-31 | 2024-01-31 | 0d |  |  |  |  |  | SI Design | PP | DBT | 5.14 | Paul Pettitt | Design, Build & Test (PIT) | Complete | COMPLETE | T3-DB-0098 | DAG | T3 | 4/8 - add as t3 milestones. Awaiting approval at TMAG |  |
| 135 | 1.3.4.7.3 | Interim Release 7 Deployed to SIT |  | 10d | 2024-05-27 A | 2024-06-07 A | 134FS+82d | 100% |  | 2024-05-27 | 2024-06-07 | 10d |  |  |  |  |  | SI Testing | PP | DBT | 5.16 |  |  | Complete | COMPLETE |  |  |  |  |  |
| 136 | 1.3.4.8 | **Interim release 8** |  | 243d | 2024-02-14 A | 2025-01-17 |  | 85% | 35.85d | 2024-02-14 | 2024-11-13 | 143d |  |  | 764d |  | -0 | N/A | N/A | DBT | 5.5 | N/A | Design, Build & Test (PIT) |  |  |  | DAG |  |  |  |
| 137 | 1.3.4.8.1 | Update baselined artefacts |  | 36d | 2024-02-14 A | 2024-04-03 A |  | 100% |  | 2024-02-14 | 2024-04-03 | 36d |  |  |  | start no earlier than 2024-02-14 |  | SI Design | PP | DBT | 5.5 | Paul Pettitt | Design, Build & Test (PIT) | Complete | COMPLETE |  |  |  |  |  |
| 138 | 1.3.4.8.2 | Interim release 8 Go live | milestone | 0d | 2024-04-03 A | 2024-04-03 A | 137 | 100% |  | 2024-04-03 | 2024-04-03 | 0d |  |  |  | start no earlier than 2024-01-10 |  | SI Design | PP | DBT | 5.14 | Paul Pettitt | Design, Build & Test (PIT) | Complete | COMPLETE | T3-DB-0099 | DAG | T3 | 4/8 - add as t3 milestones. Awaiting approval at TMAG |  |
| 139 | 1.3.4.8.3 | **Interim Release 8.3 - Maintenance Window** |  | 11d | 2024-10-07 A | 2024-10-21 A |  | 100% |  | 2024-10-07 | 2024-10-21 | 0d |  |  |  |  |  | Design |  | DBT | 6.0 |  |  | Overdue Start |  |  |  |  |  | -686.67 |
| 140 | 1.3.4.8.3.1 | Interim Release 8.3 'effective from date' to SIT A | milestone | 0d | 2024-10-21 A | 2024-10-21 A | 138FS+143d | 100% |  | 2024-10-21 | 2024-10-21 | 10d |  |  |  |  |  | SI Testing | PP | DBT | 5.16 | Roger Robar |  | Complete | COMPLETE |  |  |  |  |  |
| 141 | 1.3.4.8.3.2 | Interim Release 8.3 'effective from date' to SIT B | milestone | 0d | 2024-10-07 A | 2024-10-07 A | 140SS-11d | 100% |  | 2024-10-07 | 2024-10-07 | 0d |  |  |  |  |  | Design |  | DBT | 5.16 |  |  | Complete | COMPLETE |  |  |  |  |  |
| 142 | 1.3.4.8.4 | **Interim Release 8.4** |  | 49d | 2024-09-25 A | 2024-12-02 |  | 57% | 21d | 2024-09-25 | 2024-11-13 | 0d |  |  | 798d |  |  | Design |  | DBT | 6.1 | Paul Pettitt |  | Overdue Start |  |  | DAG |  |  | -694.67 |
| 143 | 1.3.4.8.4.1 | Update baselined artefacts |  | 8d | 2024-09-25 A | 2024-10-04 A |  | 100% |  | 2024-09-25 | 2024-10-04 | 0d |  |  |  | start no earlier than 2024-09-25 |  | Design |  | DBT | 6.1 | Paul Pettitt |  | Complete | COMPLETE |  |  |  |  |  |
| 144 | 1.3.4.8.4.2 | Interim Release 8.4 Published | milestone | 0d | 2024-10-16 A | 2024-10-16 A | 143FS+8d | 100% |  | 2024-10-16 | 2024-10-16 | 0d |  |  |  | start no earlier than 2024-10-09 |  | Design |  | DBT | 6.1 | Paul Pettitt |  | Complete | COMPLETE | T3-DB-0184 | DAG | T3 |  |  |
| 145 | 1.3.4.8.4.3 | Interim Release 8.4 Deployed to SIT by Participants |  | 6d | 2024-11-25 A | 2024-12-02 | 144FS+25d |  | 6d | 2024-11-13 | 2024-11-13 | 0d |  |  | 798d |  |  | Design |  | DBT | 6.12 | Paul Pettitt |  | Red | RED |  |  |  |  | -1.67 |
| 146 | 1.3.4.8.5 | **Interim Release 8.5** |  | 68d | 2024-10-16 A | 2025-01-17 |  | 73% | 18.55d | 2024-10-16 | 2024-12-04 |  |  |  | 764d |  |  | Design |  | DBT | 6.11 | Paul Pettitt |  | Overdue Start |  |  | DAG |  |  | -728.67 |
| 147 | 1.3.4.8.5.1 | Update baselined artefacts |  | 8d | 2024-10-16 A | 2024-10-25 A |  | 100% |  | 2024-10-16 | 2024-10-25 |  |  |  |  | start no earlier than 2024-10-16 |  | Design |  | DBT | 6.11 | Paul Pettitt |  | Complete | COMPLETE |  |  |  |  |  |
| 148 | 1.3.4.8.5.2 | Interim Release 8.5 Published | milestone | 0d | 2024-11-06 A | 2024-11-06 A | 147FS+8d | 100% |  | 2024-11-06 | 2024-11-06 |  |  |  |  |  |  | Design |  | DBT | 6.11 | Paul Pettitt |  | Complete | COMPLETE | T3-DB-0185 | DAG | T3 |  |  |
| 149 | 1.3.4.8.5.3 | Interim Release 8.5 Deployed to SIT by Participants |  | 3d | 2025-01-15 | 2025-01-17 | 148FS+49d |  |  | 2024-12-04 | 2024-12-04 |  |  |  | 764d |  |  | Design |  | DBT | 6.12 | Paul Pettitt |  | Red | RED |  |  |  |  | 49.33 |
| 150 | 1.3.5 | **Queries Support / Knowledgebase & Tool Roll-Out (Systems)** |  | 325d | 2023-01-03 A | 2024-04-01 A |  | 100% |  | 2023-01-03 | 2024-04-01 | 325d | 2023-01-03 | 2024-04-01 |  |  |  | N/A | N/A | DBT | 5.0 | N/A | Design, Build & Test (PIT) |  |  |  |  |  |  |  |
| 151 | 1.3.5.1 | **Query Management** |  | 325d | 2023-01-03 A | 2024-04-01 A |  | 100% |  | 2023-01-03 | 2024-04-01 | 325d | 2023-01-03 | 2024-04-01 |  |  |  | N/A | N/A | DBT | 5.0 | N/A | Design, Build & Test (PIT) |  |  |  |  |  |  |  |
| 152 | 1.3.5.1.1 | Respond to Participant Queries |  | 325d | 2023-01-03 A | 2024-04-01 A |  | 100% |  | 2023-01-03 | 2024-04-01 | 325d | 2023-01-03 | 2024-04-01 |  | must start on 2023-01-03 |  | SI Design | PP | DBT | 5.0 | Paul Pettitt | Design, Build & Test (PIT) | Complete | COMPLETE |  |  |  | 11/8 - runs out to end of the programme |  |
| 153 | 1.3.5.1.2 | Respond to Programme Queries |  | 325d | 2023-01-03 A | 2024-04-01 A | 152SS | 100% |  | 2023-01-03 | 2024-04-01 | 325d | 2023-01-03 | 2024-04-01 |  |  |  | SI Design | PP | DBT | 5.0 | Paul Pettitt | Design, Build & Test (PIT) | Complete | COMPLETE |  |  |  | 11/8 - runs out to end of the programme |  |

Notes:
- 144: 12/11/24 - Amended the milestone ID to align to the publication of 8.4, rather than the summary task.
- 145: 12/11/24 - Forecast delay due to St Clements, C&C and Avenade needing time to design, develop and test the solution.
- 148: 12/11/24 - Amended the milestone ID to align to the publication of 8.5, rather than the summary task.
- 149: 12/11/24 - Forecast delay due to St Clements needing time to design, develop and test the solution to CR056.

| ID | WBS | Task | Duration | Start | Finish | Predecessors | Complete | Remaining | Baseline start | Baseline finish | Baseline duration | Baseline 1 start | Baseline 1 finish | Total slack | Constraint | Baseline cost | Responsible | Involved | Text9 | Update Version | MHHS Resource Name | MHHS Programme Phase | Sched Status | RAG |
| --- | --- | --- | --- | --- | --- | --- | --- | --- | --- | --- | --- | --- | --- | --- | --- | --- | --- | --- | --- | --- | --- | --- | --- | --- |
| 154 | 1.3.5.2 | **Query Support tooling (FreshDesk)** | 23d | 2023-06-01 A | 2023-07-03 A |  | 100% |  | 2023-06-01 | 2023-07-03 | 23d | 2023-06-01 | 2023-07-03 |  |  |  | N/A | N/A | DBT | 5.0 | N/A | Design, Build & Test (PIT) |  |  |
| 155 | 1.3.5.2.1 | Migrate to Standalone Freshdesk | 10d | 2023-06-01 A | 2023-06-14 A |  | 100% |  | 2023-06-01 | 2023-06-14 | 10d | 2023-06-01 | 2023-06-14 |  | must start on 2023-06-01 |  | SI Design |  | DBT | 5.0 | Paul Pettitt | Design, Build & Test (PIT) | Complete | COMPLETE |
| 156 | 1.3.5.2.2 | Develop reporting dashboard | 5d | 2023-06-15 A | 2023-06-21 A | 155 | 100% |  | 2023-06-15 | 2023-06-21 | 5d | 2023-06-15 | 2023-06-21 |  |  |  | SI Design |  | DBT | 5.0 | Paul Pettitt | Design, Build & Test (PIT) | Complete | COMPLETE |
| 157 | 1.3.5.2.3 | Issue to SRO for Review | 5d | 2023-06-22 A | 2023-06-28 A | 156 | 100% |  | 2023-06-22 | 2023-06-28 | 5d | 2023-06-22 | 2023-06-28 |  |  |  | SI Design |  | DBT | 5.0 | Paul Pettitt | Design, Build & Test (PIT) | Complete | COMPLETE |
| 158 | 1.3.5.2.4 | Update following review | 2d | 2023-06-29 A | 2023-06-30 A | 157 | 100% |  | 2023-06-29 | 2023-06-30 | 2d | 2023-06-29 | 2023-06-30 |  |  |  | SI Design |  | DBT | 5.0 | Paul Pettitt | Design, Build & Test (PIT) | Complete | COMPLETE |
| 159 | 1.3.5.2.5 | Sign off | 1d | 2023-07-03 A | 2023-07-03 A | 158 | 100% |  | 2023-07-03 | 2023-07-03 | 1d | 2023-07-03 | 2023-07-03 |  |  |  | SI Design |  | DBT | 5.0 | Paul Pettitt | Design, Build & Test (PIT) | Complete | COMPLETE |
| 160 | 1.3.5.3 | **KnowledgeBase Development** | 72d | 2023-06-01 A | 2023-09-08 A |  | 100% |  | 2023-06-01 | 2023-09-08 | 72d | 2023-06-01 | 2023-09-08 |  |  |  | N/A | N/A | DBT | 5.0 | N/A | Design, Build & Test (PIT) |  |  |
| 161 | 1.3.5.3.1 | Define Scope of KB | 1d | 2023-06-01 A | 2023-06-01 A | 155SS | 100% |  | 2023-06-01 | 2023-06-01 | 1d | 2023-06-01 | 2023-06-01 |  |  |  | SI Design |  | DBT | 5.0 | Paul Pettitt | Design, Build & Test (PIT) | Complete | COMPLETE |
| 162 | 1.3.5.3.2 | Capture Existing KB artefacts | 20d | 2023-06-02 A | 2023-06-29 A | 161 | 100% |  | 2023-06-02 | 2023-06-29 | 20d | 2023-06-02 | 2023-06-29 |  |  |  | SI Design |  | DBT | 5.0 | Paul Pettitt | Design, Build & Test (PIT) | Complete | COMPLETE |
| 163 | 1.3.5.3.3 | Tag artefacts | 5d | 2023-06-30 A | 2023-07-06 A | 162 | 100% |  | 2023-06-30 | 2023-07-06 | 5d | 2023-06-30 | 2023-07-06 |  |  |  | SI Design |  | DBT | 5.0 | Paul Pettitt | Design, Build & Test (PIT) | Complete | COMPLETE |
| 164 | 1.3.5.3.4 | Develop Participant Interfaces | 20d | 2023-07-07 A | 2023-08-03 A | 163 | 100% |  | 2023-07-07 | 2023-08-03 | 20d | 2023-07-07 | 2023-08-03 |  |  |  | SI Design |  | DBT | 5.0 | Paul Pettitt | Design, Build & Test (PIT) | Complete | COMPLETE |
| 165 | 1.3.5.3.5 | Promote to Collaboration Portal | 21d | 2023-08-04 A | 2023-09-01 A | 164 | 100% |  | 2023-08-04 | 2023-09-01 | 21d | 2023-08-04 | 2023-09-01 |  |  |  | SI Design |  | DBT | 5.0 | Paul Pettitt | Design, Build & Test (PIT) | Complete | COMPLETE |
| 166 | 1.3.5.3.6 | Link into FreshDesk | 5d | 2023-09-04 A | 2023-09-08 A | 165 | 100% |  | 2023-09-04 | 2023-09-08 | 5d | 2023-09-04 | 2023-09-08 |  |  |  | SI Design |  | DBT | 5.0 | Paul Pettitt | Design, Build & Test (PIT) | Complete | COMPLETE |
| 167 | 1.3.6 | **PP Design, Build & Test (DBT)** | 1221d? | 2022-10-31 A | 2027-07-05 |  | 82% | 216.25d? | 2022-10-31 | 2027-07-05 | 495d | 2022-10-31 | 2026-02-16 | 123d |  | -0 | N/A | N/A | DBT | 5.0 | N/A | Design, Build & Test (PIT) |  |  |
| 168 | 1.3.6.1 | **PP Impact Assessment, Planning & Procurement** | 110d | 2022-10-31 A | 2023-03-31 A |  | 100% |  | 2022-10-31 | 2023-03-31 | 110d | 2022-10-31 | 2023-03-31 |  |  |  | N/A | N/A | DBT | 5.0 | N/A | Design, Build & Test (PIT) |  |  |
| 169 | 1.3.6.1.1 | **PP Impact Assessment** | 67d | 2022-10-31 A | 2023-01-31 A |  | 100% |  | 2022-10-31 | 2023-01-31 | 67d | 2022-10-31 | 2023-01-31 |  |  |  | N/A | N/A | DBT | 5.0 | N/A | Design, Build & Test (PIT) |  |  |
| 170 | 1.3.6.1.1.1 | Develop heatmap for impact of MHHS | 67d | 2022-10-31 A | 2023-01-31 A | 47 | 100% |  | 2022-10-31 | 2023-01-31 | 67d | 2022-10-31 | 2023-01-31 |  |  |  | PP |  | DBT | 5.0 | PP | Design, Build & Test (PIT) | Complete | COMPLETE |
| 171 | 1.3.6.1.1.2 | Develop detailed impact assessment | 67d | 2022-10-31 A | 2023-01-31 A | 47 | 100% |  | 2022-10-31 | 2023-01-31 | 67d | 2022-10-31 | 2023-01-31 |  |  |  | PP |  | DBT | 5.0 | PP | Design, Build & Test (PIT) | Complete | COMPLETE |
| 172 | 1.3.6.1.2 | **PP Planning** | 67d | 2022-10-31 A | 2023-01-31 A |  | 100% |  | 2022-10-31 | 2023-01-31 | 67d | 2022-10-31 | 2023-01-31 |  |  |  | N/A | N/A | DBT | 5.0 | N/A | Design, Build & Test (PIT) |  |  |
| 173 | 1.3.6.1.2.1 | Develop detailed short-term plan | 23d | 2022-10-31 A | 2022-11-30 A | 47 | 100% |  | 2022-10-31 | 2022-11-30 | 23d | 2022-10-31 | 2022-11-30 |  |  |  | PP |  | DBT | 5.0 | PP | Design, Build & Test (PIT) | Complete | COMPLETE |
| 174 | 1.3.6.1.2.2 | Develop overall project plan for implementation | 67d | 2022-10-31 A | 2023-01-31 A | 47 | 100% |  | 2022-10-31 | 2023-01-31 | 67d | 2022-10-31 | 2023-01-31 |  |  |  | PP |  | DBT | 5.0 | PP | Design, Build & Test (PIT) | Complete | COMPLETE |
| 175 | 1.3.6.1.2.3 | Develop procurement plan | 67d | 2022-10-31 A | 2023-01-31 A | 47 | 100% |  | 2022-10-31 | 2023-01-31 | 67d | 2022-10-31 | 2023-01-31 |  |  |  | PP |  | DBT | 5.0 | PP | Design, Build & Test (PIT) | Complete | COMPLETE |
| 176 | 1.3.6.1.3 | **PP Software/Service Procurement** | 110d | 2022-10-31 A | 2023-03-31 A |  | 100% |  | 2022-10-31 | 2023-03-31 | 110d | 2022-10-31 | 2023-03-31 |  |  |  | N/A | N/A | DBT | 5.0 | N/A | Design, Build & Test (PIT) |  |  |
| 177 | 1.3.6.1.3.1 | Run tender process | 67d | 2022-10-31 A | 2023-01-31 A | 47 | 100% |  | 2022-10-31 | 2023-01-31 | 67d | 2022-10-31 | 2023-01-31 |  |  |  | PP |  | DBT | 5.0 | PP | Design, Build & Test (PIT) | Complete | COMPLETE |
| 178 | 1.3.6.1.3.2 | Select provider & sign commercials | 43d | 2023-02-01 A | 2023-03-31 A | 177 | 100% |  | 2023-02-01 | 2023-03-31 | 43d | 2023-02-01 | 2023-03-31 |  |  |  | PP |  | DBT | 5.0 | PP | Design, Build & Test (PIT) | Complete | COMPLETE |

| ID | WBS | Task | Duration | Start | Finish | Predecessors | Complete | Remaining | Baseline start | Baseline finish | Baseline duration | Total slack | Free slack | Constraint | Responsible | Text9 | Task Status | Update Version | Sched Status | MHHS Resource Name | RAG |
| --- | --- | --- | --- | --- | --- | --- | --- | --- | --- | --- | --- | --- | --- | --- | --- | --- | --- | --- | --- | --- | --- |
| 179 | 1.3.6.2 | **Design Handover** | 741d? | 2024-09-02 A | 2027-07-05 |  | 2% | 722.52d? | 2024-09-02 | 2027-07-05 | 0d | 123d |  |  | Design | DBT | -694.67 | 6.1 | Overdue Start | Paul Pettitt | RED |
| 180 | 1.3.6.2.1 | **Creation of the Configuration Management Database** | 14d | 2024-09-02 | 2024-09-19 |  |  |  | 2024-09-02 | 2024-09-19 | 0d | 850d |  |  | Design | DBT | -701.67 | 6.1 | Overdue Start | Paul Pettitt | RED |
| 181 | 1.3.6.2.1.1 | Identify all baselined design artefacts | 9d | 2024-09-02 | 2024-09-12 |  |  |  | 2024-09-02 | 2024-09-12 | 0d | 850d | 0d | start no earlier than 2024-09-02 | Design | DBT | -85.67 | 6.1 | Overdue Start | Paul Pettitt | RED |
| 182 | 1.3.6.2.1.2 | Create CMBD | 5d | 2024-09-13 | 2024-09-19 | 181 |  |  | 2024-09-13 | 2024-09-19 | 0d | 850d |  |  | Design | DBT | -74.67 | 6.1 | Overdue Start | Paul Pettitt | RED |
| 183 | 1.3.6.2.2 | **Knowledge Transfer** | 41d? | 2024-09-02 | 2024-10-28 |  |  |  | 2024-09-02 | 2024-10-28 | 0d | 823d |  |  | Design | DBT | -701.67 | 6.1 | Overdue Start | Paul Pettitt | RED |
| 184 | 1.3.6.2.2.1 | Elexon to document knowledge transfer requirements | 9d? | 2024-09-02 | 2024-09-12 |  |  |  | 2024-09-02 | 2024-09-12 | 0d | 834d | 0d | start no earlier than 2024-09-02 | Design | DBT | -85.67 | 6.1 | Overdue Start | Paul Pettitt | RED |
| 185 | 1.3.6.2.2.2 | Review Requirements | 5d | 2024-09-13 | 2024-09-19 | 184 |  |  | 2024-09-13 | 2024-09-19 | 0d | 834d | 0d |  | Design | DBT | -74.67 | 6.1 | Overdue Start | Paul Pettitt | RED |
| 186 | 1.3.6.2.2.3 | Agree Success Criteria | 10d | 2024-09-20 | 2024-10-03 | 185 |  |  | 2024-09-20 | 2024-10-03 | 0d | 834d | 0d |  | Design | DBT | -67.67 | 6.1 | Overdue Start | Paul Pettitt | RED |
| 187 | 1.3.6.2.2.4 | Identify Key personel with Elexon | 3d | 2024-10-04 | 2024-10-08 | 186 |  |  | 2024-10-04 | 2024-10-08 | 0d | 834d | 0d |  | Design | DBT | -53.67 | 6.1 | Overdue Start | Paul Pettitt | RED |
| 188 | 1.3.6.2.2.5 | Draft Agenda for initial meeting | 1d? | 2024-10-09 | 2024-10-09 | 187 |  |  | 2024-10-09 | 2024-10-09 | 0d | 834d | 0d |  | Design | DBT | -48.67 | 6.1 | Overdue Start | Paul Pettitt | RED |
| 189 | 1.3.6.2.2.6 | Define cadence for handover sessions | 2d | 2024-10-10 | 2024-10-11 | 188 |  |  | 2024-10-10 | 2024-10-11 | 0d | 834d |  |  | Design | DBT | -47.67 | 6.1 | Overdue Start | Paul Pettitt | RED |
| 190 | 1.3.6.2.2.7 | Share Design Information | 20d | 2024-09-02 | 2024-09-27 |  |  |  | 2024-09-02 | 2024-09-27 | 0d | 844d |  | start no earlier than 2024-09-02 | Design | DBT | -85.67 | 6.1 | Overdue Start | Paul Pettitt | RED |
| 191 | 1.3.6.2.2.8 | Conduct Initial Handover Session | 20d? | 2024-10-01 | 2024-10-28 |  |  |  | 2024-10-01 | 2024-10-28 | 0d | 823d |  | start no earlier than 2024-10-01 | Design | DBT | -56.67 | 6.1 | Overdue Start | Paul Pettitt | RED |
| 192 | 1.3.6.2.3 | **Triage Sessions** | 131d? | 2024-10-01 | 2025-04-01 |  |  |  | 2024-10-01 | 2025-04-01 | 0d | 712d |  |  | Design | DBT | -701.67 | 6.1 | Overdue Start | Paul Pettitt | RED |
| 193 | 1.3.6.2.3.1 | Design Triage Sessions | 131d? | 2024-10-01 | 2025-04-01 |  |  |  | 2024-10-01 | 2025-04-01 | 0d | 712d |  | start no earlier than 2024-10-01 | Design | DBT | -56.67 | 6.1 | Overdue Start | Paul Pettitt | RED |
| 194 | 1.3.6.2.3.2 | Test Triage Sessions | 131d? | 2024-10-01 | 2025-04-01 |  |  |  | 2024-10-01 | 2025-04-01 | 0d | 712d |  | finish no earlier than 2025-04-01 | Design | DBT | -56.67 | 6.1 | Overdue Start | Paul Pettitt | RED |
| 195 | 1.3.6.2.4 | **Knowledge Base** | 9d | 2024-09-02 A | 2024-09-12 A |  | 100% |  | 2024-09-02 | 2024-09-12 | 0d |  |  |  | Design | DBT | -701.67 | 6.1 | Overdue Start | Paul Pettitt | COMPLETE |
| 196 | 1.3.6.2.4.1 | Document Knowledge base update process | 4d | 2024-09-02 A | 2024-09-05 A |  | 100% |  | 2024-09-02 | 2024-09-05 | 0d |  |  | start no earlier than 2024-09-02 | Design | DBT |  | 6.1 | Complete | Paul Pettitt | COMPLETE |
| 197 | 1.3.6.2.4.2 | Document Design updates to Collaboration Base | 5d | 2024-09-06 A | 2024-09-12 A |  | 100% |  | 2024-09-06 | 2024-09-12 | 0d |  |  | start no earlier than 2024-09-06 | Design | DBT |  | 6.1 | Complete | Paul Pettitt | COMPLETE |
| 198 | 1.3.6.2.5 | **FreshDesk** | 30d? | 2025-02-03 | 2025-03-14 |  |  |  | 2025-02-03 | 2025-03-14 | 0d | 724d |  |  | Design | DBT | -701.67 | 6.1 | Overdue Start | Paul Pettitt | GREEN |
| 199 | 1.3.6.2.5.1 | Agree Indicative Handover of FreshDesk Calls to Service Now | 4d | 2025-02-03 | 2025-02-06 |  |  |  | 2025-02-03 | 2025-02-06 | 0d | 750d |  | start no earlier than 2025-02-03 | Design | DBT | 68.33 | 6.1 | Green | Paul Pettitt | GREEN |
| 200 | 1.3.6.2.5.2 | Prepare Comms to Industry | 10d | 2025-02-07 | 2025-02-20 |  |  |  | 2025-02-07 | 2025-02-20 | 0d | 740d |  | start no earlier than 2025-02-07 | Design | DBT | 72.33 | 6.1 | Green | Paul Pettitt | GREEN |
| 201 | 1.3.6.2.5.3 | Issue Comms to Industry | 1d? | 2025-02-21 | 2025-02-21 |  |  |  | 2025-02-21 | 2025-02-21 | 0d | 739d |  | start no earlier than 2025-02-21 | Design | DBT | 86.33 | 6.1 | Green | Paul Pettitt | GREEN |
| 202 | 1.3.6.2.5.4 | Redirect Design Mailbox to Service Now | 1d? | 2025-03-03 | 2025-03-03 |  |  |  | 2025-03-03 | 2025-03-03 | 0d | 733d |  | start no earlier than 2025-03-03 | Design | DBT | 96.33 | 6.1 | Green | Paul Pettitt | GREEN |
| 203 | 1.3.6.2.5.5 | Archive Freshdesk calls | 5d | 2025-03-03 | 2025-03-07 |  |  |  | 2025-03-03 | 2025-03-07 | 0d | 729d |  | start no earlier than 2025-03-03 | Design | DBT | 96.33 | 6.1 | Green | Paul Pettitt | GREEN |
| 204 | 1.3.6.2.5.6 | Decommission FreshDesk | 5d | 2025-03-10 | 2025-03-14 |  |  |  | 2025-03-10 | 2025-03-14 | 0d | 724d |  | start no earlier than 2025-03-10 | Design | DBT | 103.33 | 6.1 | Green | Paul Pettitt | GREEN |

Notes:
- 179: 12/11/24 - Design Handover activities on hold and with SRO for escalation and resolution.
- 180: 12/11/24 - Design Handover activities on hold and with SRO for escalation and resolution.
- 181: 12/11/24 - Design Handover activities on hold and with SRO for escalation and resolution.
- 182: 12/11/24 - Design Handover activities on hold and with SRO for escalation and resolution.
- 183: 12/11/24 - Design Handover activities on hold and with SRO for escalation and resolution.
- 184: 12/11/24 - Design Handover activities on hold and with SRO for escalation and resolution.
- 185: 12/11/24 - Design Handover activities on hold and with SRO for escalation and resolution.
- 186: 12/11/24 - Design Handover activities on hold and with SRO for escalation and resolution.
- 187: 12/11/24 - Design Handover activities on hold and with SRO for escalation and resolution.
- 188: 12/11/24 - Design Handover activities on hold and with SRO for escalation and resolution.
- 189: 12/11/24 - Design Handover activities on hold and with SRO for escalation and resolution.
- 190: 12/11/24 - Design Handover activities on hold and with SRO for escalation and resolution.
- 191: 12/11/24 - Design Handover activities on hold and with SRO for escalation and resolution.
- 192: 12/11/24 - Design Handover activities on hold and with SRO for escalation and resolution.
- 193: 12/11/24 - Design Handover activities on hold and with SRO for escalation and resolution.
- 194: 12/11/24 - Design Handover activities on hold and with SRO for escalation and resolution.

| ID | WBS | Task | Type | Duration | Start | Finish | Predecessors | Complete | Remaining | Baseline start | Baseline finish | Baseline duration | Baseline 1 start | Baseline 1 finish | Total slack | Free slack | Constraint | Baseline cost | Responsible | Text9 | Task Status | Update Version | Sched Status | MHHS Resource Name | RAG | Involved | MHHS Programme Phase | Milestone ID | Text29 | Tier | Artefact ID |
| --- | --- | --- | --- | --- | --- | --- | --- | --- | --- | --- | --- | --- | --- | --- | --- | --- | --- | --- | --- | --- | --- | --- | --- | --- | --- | --- | --- | --- | --- | --- | --- |
| 205 | 1.3.6.2.6 | **iServer** |  | 611d? | 2025-03-03 A | 2027-07-05 |  | 5% | 580.45d? | 2025-03-03 | 2027-07-05 | 0d |  |  |  |  |  |  | Design | DBT | -701.67 | 6.1 | Overdue Start | Paul Pettitt | GREEN |  |  |  |  |  |  |
| 206 | 1.3.6.2.6.1 | Gather Licensing information |  | 1d? | 2025-03-03 A | 2025-03-03 A |  | 100% |  | 2025-03-03 | 2025-03-03 | 0d |  |  |  |  | start no earlier than 2025-03-03 |  | Design | DBT |  | 6.1 | Complete | Paul Pettitt | COMPLETE |  |  |  |  |  |  |
| 207 | 1.3.6.2.6.2 | Clear down old information |  | 5d | 2025-03-03 | 2025-03-07 |  |  |  | 2025-03-03 | 2025-03-07 | 0d |  |  | 715d | 0d |  |  | Design | DBT | 96.33 | 6.1 | Green | Paul Pettitt | GREEN |  |  |  |  |  |  |
| 208 | 1.3.6.2.6.3 | Clear down accounts |  | 2d | 2025-03-10 | 2025-03-11 | 207 |  |  | 2025-03-10 | 2025-03-11 | 0d |  |  | 715d | 14d | start no earlier than 2025-03-10 |  | Design | DBT | 103.33 | 6.1 | Green | Paul Pettitt | GREEN |  |  |  |  |  |  |
| 209 | 1.3.6.2.6.4 | Identify Collaboration Base Design Dependencies on iServer |  | 2d | 2025-04-01 | 2025-04-02 | 208 |  |  | 2025-04-01 | 2025-04-02 | 0d |  |  | 701d | 0d | start no earlier than 2025-04-01 |  | Design | DBT | 125.33 | 6.1 | Green | Paul Pettitt | GREEN |  |  |  |  |  |  |
| 210 | 1.3.6.2.6.5 | Remove Design dependencies |  | 5d | 2025-04-03 | 2025-04-09 | 209 |  |  | 2025-04-03 | 2025-04-09 | 0d |  |  | 701d | 0d | start no earlier than 2025-04-03 |  | Design | DBT | 127.33 | 6.1 | Green | Paul Pettitt | GREEN |  |  |  |  |  |  |
| 211 | 1.3.6.2.6.6 | Close down iServer |  | 5d | 2025-04-10 | 2025-04-16 | 210 |  |  | 2025-04-10 | 2025-04-16 | 0d |  |  | 701d |  | start no earlier than 2025-04-10 |  | Design | DBT | 134.33 | 6.1 | Green | Paul Pettitt | GREEN |  |  |  |  |  |  |
| 212 | 1.3.6.3 | **Central Systems DBT** |  | 325d | 2022-10-31 A | 2024-01-26 A |  | 100% |  | 2022-10-31 | 2024-01-26 | 345d | 2022-10-31 | 2024-05-13 |  |  |  | -0 | N/A | DBT | -316.67 | 5.0 |  | N/A |  | N/A | Design, Build & Test (PIT) |  |  |  |  |
| 213 | 1.3.6.3.1 | **Elexon Central Systems DBT CIT (Entering at Interval 1)** |  | 248d | 2022-10-31 A | 2023-10-11 A |  | 100% |  | 2022-10-31 | 2023-10-11 | 249d | 2022-10-31 | 2023-09-29 |  |  |  | -0 | N/A | DBT |  | 5.0 |  | N/A |  | N/A | Design, Build & Test (PIT) |  |  |  |  |
| 214 | 1.3.6.3.1.1 | **Design and Build** |  | 235d | 2022-10-31 A | 2023-09-22 A |  | 100% |  | 2022-10-31 | 2023-09-22 | 240d | 2022-10-31 | 2023-09-29 |  |  |  |  | N/A | DBT | -259.67 | 5.0 |  | N/A |  | N/A | Design, Build & Test (PIT) |  |  |  |  |
| 215 | 1.3.6.3.1.1.1 | Helix Design and Build |  | 235d | 2022-10-31 A | 2023-09-22 A | 2 | 100% |  | 2022-10-31 | 2023-09-22 | 240d | 2022-10-31 | 2023-09-29 |  |  |  |  | PP | DBT |  | 5.0 | Complete |  | COMPLETE | SI Test | Design, Build & Test (PIT) |  |  |  |  |
| 216 | 1.3.6.3.1.2 | **Test Approach & Plan** |  | 235d | 2022-10-31 A | 2023-09-22 A |  | 100% |  | 2022-10-31 | 2023-09-22 | 235d | 2022-10-31 | 2023-07-21 |  |  |  | -0 | N/A | DBT |  | 5.0 |  | N/A |  | N/A | Design, Build & Test (PIT) |  |  |  |  |
| 217 | 1.3.6.3.1.2.1 | Develop Test Approach & Plan |  | 180d | 2022-10-31 A | 2023-07-07 A |  | 100% |  | 2022-10-31 | 2023-07-07 | 180d | 2022-10-31 | 2023-07-07 |  |  |  |  | PP | DBT |  | 5.0 | Complete |  | COMPLETE | SI Test | Design, Build & Test (PIT) |  |  |  |  |
| 218 | 1.3.6.3.1.2.2 | Elexon Central Systems Test Approach & Plan (PIT) submitted to Programme for assurance | milestone | 0d | 2023-07-13 A | 2023-07-13 A | 217FF+4d | 100% |  | 2023-07-13 | 2023-07-13 | 0d | 2023-07-07 | 2023-07-07 |  |  |  |  | PP | DBT |  | 5.0 | Complete |  | COMPLETE | SI Test | Design, Build & Test (PIT) | T3-DB-0029 | SITAG | T3 |  |
| 219 | 1.3.6.3.1.2.3 | Elexon Central Systems Test Approach & Plan (PIT) V2 resubmitted to Programme for assurance | milestone, manual | 0d | 2023-07-27 A | 2023-07-27 A | 218FS+9d | 100% |  | 2023-07-27 | 2023-07-27 | 0d |  |  |  |  |  |  | PP | DBT |  | 5.4 | Complete |  | COMPLETE | SI Test | Design, Build & Test (PIT) |  |  |  |  |
| 220 | 1.3.6.3.1.2.4 | Elexon Central Systems Test Approach & Plan (PIT) V3 resubmitted to Programme for assurance | milestone | 0d | 2023-08-18 A | 2023-08-18 A | 219FS+17d | 100% |  | 2023-08-18 | 2023-08-18 | 0d |  |  |  |  |  |  | PP | DBT |  | 5.4 | Complete |  | COMPLETE | SI Test | Design, Build & Test (PIT) |  |  |  |  |
| 221 | 1.3.6.3.1.2.5 | Elexon Central Systems Test approach and plan MHHS Review Completed | milestone | 0d | 2023-09-22 A | 2023-09-22 A | 220FS+25d | 100% |  | 2023-09-22 | 2023-09-22 | 0d | 2023-07-10 | 2023-07-21 |  |  |  |  | SI Test | DBT |  | 5.8 | Complete |  | COMPLETE | PP | Design, Build & Test (PIT) | T3-DB-0106 | SITAG | T3 |  |
| 222 | 1.3.6.3.1.3 | **Test Readiness Report** |  | 16d | 2023-07-28 A | 2023-08-18 A |  | 100% |  | 2023-07-28 | 2023-08-18 | 51d | 2023-07-21 | 2023-09-29 |  |  |  |  | N/A | DBT |  | 5.0 |  | N/A |  | N/A | Design, Build & Test (PIT) |  |  |  |  |
| 223 | 1.3.6.3.1.3.1 | Test readiness reporting |  | 16d | 2023-07-28 A | 2023-08-18 A | 218FS+10d | 100% |  | 2023-07-28 | 2023-08-18 | 51d | 2023-07-21 | 2023-09-29 |  |  |  |  | PP | DBT |  | 5.0 | Complete |  | COMPLETE | 109 | Design, Build & Test (PIT) |  |  |  |  |
| 224 | 1.3.6.3.1.4 | **Requirements to test Traceability Matrix (RTTM)** |  | 35d | 2023-08-04 A | 2023-09-22 A |  | 100% |  | 2023-08-04 | 2023-09-22 | 35d | 2022-10-31 | 2023-08-18 |  |  |  | -0 | N/A | DBT |  | 5.0 |  | N/A |  | N/A | Design, Build & Test (PIT) |  |  |  |  |
| 225 | 1.3.6.3.1.4.1 | Elexon Central Systems RTTM submitted to Programme for assurance | milestone | 0d | 2023-08-04 A | 2023-08-04 A | 218 | 100% |  | 2023-08-04 | 2023-08-04 | 0d | 2023-08-04 | 2023-08-04 |  |  | start no earlier than 2023-04-28 |  | PP | DBT |  | 5.0 | Complete |  | COMPLETE | SI Test | Design, Build & Test (PIT) | T3-DB-0030 | SITAG | T3 | MHHS-ART009 |
| 226 | 1.3.6.3.1.4.2 | Elexon Central Systems RTTM MHHS Review Completed | milestone | 0d | 2023-09-22 A | 2023-09-22 A | 225FS+35d | 100% |  | 2023-09-22 | 2023-09-22 | 0d | 2023-08-07 | 2023-08-18 |  |  |  |  | SI Test | DBT |  | 5.8 | Complete |  | COMPLETE | PP | Design, Build & Test (PIT) | T3-DB-0107 | SITAG | T3 |  |
| 227 | 1.3.6.3.1.5 | **Test Scenarios** |  | 35d | 2023-08-04 A | 2023-09-22 A |  | 100% |  | 2023-08-04 | 2023-09-22 | 35d | 2022-10-31 | 2023-08-18 |  |  |  | -0 | N/A | DBT |  | 5.0 |  | N/A |  | N/A | Design, Build & Test (PIT) |  |  |  |  |
| 228 | 1.3.6.3.1.5.1 | Elexon Central Systems test scenarios submitted to Programme for assurance | milestone | 0d | 2023-08-04 A | 2023-08-04 A | 218 | 100% |  | 2023-08-04 | 2023-08-04 | 0d | 2023-08-04 | 2023-08-04 |  |  |  |  | PP | DBT |  | 5.0 | Complete |  | COMPLETE | SI Test | Design, Build & Test (PIT) | T3-DB-0032 | SITAG | T3 |  |
| 229 | 1.3.6.3.1.5.2 | Elexon Central Systems Test scenarios MHHS Review Completed | milestone | 0d | 2023-09-22 A | 2023-09-22 A | 228FS+35d | 100% |  | 2023-09-22 | 2023-09-22 | 0d | 2023-08-07 | 2023-08-18 |  |  |  |  | SI Test | DBT |  | 5.8 | Complete |  | COMPLETE | PP | Design, Build & Test (PIT) | T3-DB-0108 | SITAG | T3 |  |

| ID | WBS | Task | Type | Duration | Start | Finish | Predecessors | Complete | Baseline start | Baseline finish | Baseline duration | Baseline 1 start | Baseline 1 finish | Constraint | Baseline cost | Responsible | Involved | Text9 | Update Version | MHHS Resource Name | MHHS Programme Phase | Sched Status | RAG | Milestone ID | Text29 | Tier | Artefact ID |
| --- | --- | --- | --- | --- | --- | --- | --- | --- | --- | --- | --- | --- | --- | --- | --- | --- | --- | --- | --- | --- | --- | --- | --- | --- | --- | --- | --- |
| 230 | 1.3.6.3.1.6 | **PIT Execution** |  | 38d | 2023-08-21 A | 2023-10-11 A |  | 100% | 2023-08-21 | 2023-10-11 | 248d | 2022-10-31 | 2023-09-29 |  | -0 | N/A | N/A | DBT | 5.0 | N/A | Design, Build & Test (PIT) |  |  |  |  |  |  |
| 231 | 1.3.6.3.1.6.1 | PIT Test Execution Progress Report |  | 18d | 2023-09-04 A | 2023-09-27 A | 223FS+10d | 100% | 2023-09-04 | 2023-09-27 | 235d | 2022-10-31 | 2023-09-22 |  |  | PP | SI Test | DBT | 5.1 |  | Design, Build & Test (PIT) | Complete | COMPLETE |  |  |  |  |
| 232 | 1.3.6.3.1.6.2 | Elexon Central Systems PIT Execution |  | 28d | 2023-08-21 A | 2023-09-27 A | 223 | 100% | 2023-08-21 | 2023-09-27 | 240d | 2022-10-31 | 2023-09-29 |  |  | PP | SI Test | DBT | 5.1 |  | Design, Build & Test (PIT) | Complete | COMPLETE |  |  |  |  |
| 233 | 1.3.6.3.1.6.3 | Elexon Central Systems PIT Completion Report submitted to Programme for assurance | milestone | 0d | 2023-09-27 A | 2023-09-27 A | 232 | 100% | 2023-09-27 | 2023-09-27 | 0d | 2024-01-05 | 2024-01-05 |  |  | PP | SI Test | DBT | 5.8 |  | Design, Build & Test (PIT) | Complete | COMPLETE | T3-DB-0109 | SITAG | T3 |  |
| 234 | 1.3.6.3.1.6.4 | Elexon Central Systems PIT Completion Report MHHS Review Completed | milestone | 0d | 2023-10-11 A | 2023-10-11 A | 226, 229, 231, 233FS+10d, 221 | 100% | 2023-10-11 | 2023-10-11 | 0d |  |  |  |  | SI Test | PP | DBT | 5.8 |  | Design, Build & Test (PIT) | Complete | COMPLETE | T3-DB-0110 | SITAG | T3 |  |
| 235 | 1.3.6.3.2 | **DIP DBT CIT (Entering at Interval 1)** |  | 221d | 2023-01-02 A | 2023-11-06 A |  | 100% | 2023-01-02 | 2023-11-06 | 266d | 2022-10-31 | 2023-09-29 |  | -0 | N/A | N/A | DBT | 5.0 | N/A | Design, Build & Test (PIT) |  |  |  |  |  |  |
| 236 | 1.3.6.3.2.1 | Design |  | 80d | 2023-01-02 A | 2023-04-21 A |  | 100% | 2023-01-02 | 2023-04-21 | 80d | 2023-01-02 | 2023-04-21 | must start on 2023-01-02 |  | PP | SI Design | DBT | 5.0 |  | Design, Build & Test (PIT) | Complete | COMPLETE |  |  |  |  |
| 237 | 1.3.6.3.2.2 | Build |  | 155d | 2023-01-09 A | 2023-08-11 A | 236SS+5d | 100% | 2023-01-09 | 2023-08-11 | 155d | 2023-01-09 | 2023-08-11 |  |  | PP |  | DBT | 5.5 |  | Design, Build & Test (PIT) | Complete | COMPLETE |  |  |  |  |
| 238 | 1.3.6.3.2.3 | **Test Approach & Plan** |  | 9d | 2023-07-07 A | 2023-07-20 A |  | 100% | 2023-07-07 | 2023-07-20 | 190d | 2022-10-31 | 2023-07-21 |  |  | N/A | N/A | DBT | 5.0 | N/A | Design, Build & Test (PIT) |  |  |  |  |  |  |
| 239 | 1.3.6.3.2.3.1 | DIP Test Approach & Plan (PIT) submitted to Programme for assurance | milestone | 0d | 2023-07-07 A | 2023-07-07 A |  | 100% | 2023-07-07 | 2023-07-07 | 0d | 2023-07-07 | 2023-07-07 |  |  | PP | SI Test | DBT | 5.0 |  | Design, Build & Test (PIT) | Complete | COMPLETE | T3-DB-0026 | SITAG | T3 | MHHS-ART073 |
| 240 | 1.3.6.3.2.3.2 | DIP Test Approach & Plan (PIT) MHHS Review Completed | milestone | 0d | 2023-07-20 A | 2023-07-20 A | 239FS+9d | 100% | 2023-07-20 | 2023-07-20 | 10d | 2023-07-10 | 2023-07-21 |  |  | SI Test | PP | DBT | 5.0 |  | Design, Build & Test (PIT) | Complete | COMPLETE |  |  |  |  |
| 241 | 1.3.6.3.2.4 | **PIT Test Readiness Report** |  | 31d | 2023-07-21 A | 2023-09-01 A |  | 100% | 2023-07-21 | 2023-09-01 | 51d | 2023-07-21 | 2023-09-29 |  |  | N/A | N/A | DBT | 5.0 | N/A | Design, Build & Test (PIT) |  |  |  |  |  |  |
| 242 | 1.3.6.3.2.4.1 | Test readiness reporting |  | 31d | 2023-07-21 A | 2023-09-01 A | 239FS+9d | 100% | 2023-07-21 | 2023-09-01 | 51d | 2023-07-21 | 2023-09-29 |  |  | SI Test | 109 | DBT | 5.0 |  | Design, Build & Test (PIT) | Complete | COMPLETE |  |  |  |  |
| 243 | 1.3.6.3.2.5 | **Requirements to test Traceability Matrix (RTTM)** |  | 18d | 2023-08-04 A | 2023-08-30 A |  | 100% | 2023-08-04 | 2023-08-30 | 210d | 2022-10-31 | 2023-08-18 |  |  | N/A | N/A | DBT | 5.0 | N/A | Design, Build & Test (PIT) |  |  |  |  |  |  |
| 244 | 1.3.6.3.2.5.1 | DIP RTTM submitted to Programme for assurance | milestone | 0d | 2023-08-04 A | 2023-08-04 A | 239FS+15d | 100% | 2023-08-04 | 2023-08-04 | 0d | 2023-08-04 | 2023-08-04 |  |  | PP | SI Test | DBT | 5.6 |  | Design, Build & Test (PIT) | Complete | COMPLETE | T3-DB-0034 | SITAG | T3 | MHHS-ART009 |
| 245 | 1.3.6.3.2.5.2 | DIP RTTM MHHS Review Completed | milestone | 0d | 2023-08-30 A | 2023-08-30 A | 244FS+18d | 100% | 2023-08-30 | 2023-08-30 | 10d | 2023-08-07 | 2023-08-18 |  |  | SI Test | PP | DBT | 5.0 |  | Design, Build & Test (PIT) | Complete | COMPLETE |  |  |  |  |
| 246 | 1.3.6.3.2.6 | **Test Scenarios** |  | 22d | 2023-07-31 A | 2023-08-30 A |  | 100% | 2023-07-31 | 2023-08-30 | 206d | 2022-10-31 | 2023-08-18 |  |  | N/A | N/A | DBT | 5.0 | N/A | Design, Build & Test (PIT) |  |  |  |  |  |  |
| 247 | 1.3.6.3.2.6.1 | DIP PIT test scenarios submitted to Programme for assurance | milestone | 0d | 2023-07-31 A | 2023-07-31 A | 239FS+15d | 100% | 2023-07-31 | 2023-07-31 | 0d | 2023-08-04 | 2023-08-04 |  |  | PP | SI Test | DBT | 5.0 |  | Design, Build & Test (PIT) | Complete | COMPLETE | T3-DB-0036 | SITAG | T3 |  |
| 248 | 1.3.6.3.2.6.2 | DIP Test scenarios MHHS Review Completed | milestone | 0d | 2023-08-30 A | 2023-08-30 A | 247FS+22d | 100% | 2023-08-30 | 2023-08-30 | 10d | 2023-08-07 | 2023-08-18 |  |  | SI Test | PP | DBT | 5.0 |  | Design, Build & Test (PIT) | Complete | COMPLETE |  |  |  |  |
| 249 | 1.3.6.3.2.7 | **PIT execution** |  | 50d | 2023-08-29 A | 2023-11-06 A |  | 100% | 2023-08-29 | 2023-11-06 | 47d | 2022-10-31 | 2023-09-29 |  | -0 | N/A | N/A | DBT | 5.0 | N/A | Design, Build & Test (PIT) |  |  |  |  |  |  |
| 250 | 1.3.6.3.2.7.1 | PIT Test Execution Progress Report |  | 37d | 2023-09-01 A | 2023-10-23 A | 251FF, 242 | 100% | 2023-09-01 | 2023-10-23 | 37d | 2022-10-31 | 2023-09-22 | start no earlier than 2023-08-29 |  | PP | SI Test | DBT | 5.6 |  | Design, Build & Test (PIT) | Complete | COMPLETE |  |  |  |  |
| 251 | 1.3.6.3.2.7.2 | PIT Execution (Interim Release 1) |  | 30d | 2023-08-29 A | 2023-10-09 A |  | 100% | 2023-08-29 | 2023-10-09 | 24d | 2022-10-31 | 2023-09-29 | start no earlier than 2023-08-29 |  | PP | SI Test | DBT | 5.6 |  | Design, Build & Test (PIT) | Complete | COMPLETE |  |  |  |  |
| 252 | 1.3.6.3.2.7.3 | PIT Execution (Interim Release 2) |  | 10d | 2023-10-10 A | 2023-10-23 A | 251 | 100% | 2023-10-10 | 2023-10-23 | 10d |  |  |  |  | PP | SI Test | DBT | 5.6 |  | Design, Build & Test (PIT) | Complete | COMPLETE |  |  |  |  |
| 253 | 1.3.6.3.2.7.4 | DIP PIT Completion Report (Interim Release 1) submitted to Programme for assurance | milestone | 0d | 2023-10-09 A | 2023-10-09 A | 251 | 100% | 2023-10-09 | 2023-10-09 | 0d | 2024-01-05 | 2024-01-05 |  |  | PP | SI Test | DBT | 5.8 |  | Design, Build & Test (PIT) | Complete | COMPLETE | T3-DB-0111 | SITAG | T3 |  |
| 254 | 1.3.6.3.2.7.5 | DIP PIT Completion Report (Interim Release 1) MHHS Review Completed | milestone | 0d | 2023-10-23 A | 2023-10-23 A | 253FS+10d | 100% | 2023-10-23 | 2023-10-23 | 0d |  |  |  |  | SI Test | SI Test | DBT | 5.10 |  | Design, Build & Test (PIT) | Complete | COMPLETE | T3-DB-0112 | SITAG | T3 |  |
| 255 | 1.3.6.3.2.7.6 | DIP PIT Completion Report (Interim Release 2) submitted to Programme for assurance | milestone | 0d | 2023-10-23 A | 2023-10-23 A | 252, 250 | 100% | 2023-10-23 | 2023-10-23 | 0d | 2024-01-05 | 2024-01-05 |  |  | PP | SI Test | DBT | 5.10 |  | Design, Build & Test (PIT) | Complete | COMPLETE | T3-DB-0113 | SITAG | T3 |  |
| 256 | 1.3.6.3.2.7.7 | DIP PIT Completion Report (Interim Release 2) MHHS Review Completed | milestone | 0d | 2023-11-06 A | 2023-11-06 A | 255FS+10d | 100% | 2023-11-06 | 2023-11-06 | 0d |  |  |  |  | SI Test | SI Test | DBT | 5.14 |  | Design, Build & Test (PIT) | Complete | COMPLETE | T3-DB-0114 | SITAG | T3 |  |

Notes:
- 242: Action: 14/8 - Query from RG - IS this an SI Test deliverable or expected to be a DIP deliverable if so be more specific
- 256: Guidance: 6/10 - LC - Successor should be SIT Component Integration Testing 1 Preparation Complete but not linked as DIP test completion plus 10 day review breaks logic. Decision will be made to proceed without a conclusion of the report review

| ID | WBS | Task | Type | Duration | Start | Finish | Predecessors | Complete | Baseline start | Baseline finish | Baseline duration | Baseline 1 start | Baseline 1 finish | Constraint | Baseline cost | Responsible | Involved | Text9 | Update Version | MHHS Resource Name | MHHS Programme Phase | Sched Status | RAG | Milestone ID | Text29 | Tier | Artefact ID |
| --- | --- | --- | --- | --- | --- | --- | --- | --- | --- | --- | --- | --- | --- | --- | --- | --- | --- | --- | --- | --- | --- | --- | --- | --- | --- | --- | --- |
| 257 | 1.3.6.3.3 | **DCC (DSP) DBT SIT Functional (Entering at SIT Functional)** |  | 325d | 2022-10-31 A | 2024-01-26 A |  | 100% | 2022-10-31 | 2024-01-26 | 345d | 2022-10-31 | 2024-01-05 |  | -0 | N/A | N/A | DBT | 5.18 | N/A | Design, Build & Test (PIT) |  |  |  |  |  |  |
| 258 | 1.3.6.3.3.1 | Design |  | 67d | 2022-10-31 A | 2023-01-31 A |  | 100% | 2022-10-31 | 2023-01-31 | 67d | 2022-10-31 | 2023-01-31 |  |  | PP | SI Design | DBT | 5.18 |  | Design, Build & Test (PIT) | Complete | COMPLETE |  |  |  |  |
| 259 | 1.3.6.3.3.2 | **Test Approach & Plan** |  | 20d | 2023-11-17 A | 2023-12-15 A |  | 100% | 2023-11-17 | 2023-12-15 | 20d | 2022-10-31 | 2023-10-27 |  | -0 | N/A | N/A | DBT | 5.18 | N/A | Design, Build & Test (PIT) |  |  |  |  |  |  |
| 260 | 1.3.6.3.3.2.1 | DCC Test Approach & Plan (PIT) submitted to Programme for assurance | milestone | 0d | 2023-11-17 A | 2023-11-17 A | 258FS+208d | 100% | 2023-11-17 | 2023-11-17 | 0d | 2023-10-13 | 2023-10-13 |  |  | PP | SI Test | DBT | 5.18 |  | Design, Build & Test (PIT) | Complete | COMPLETE | T3-DB-0068 | SITAG | T3 |  |
| 261 | 1.3.6.3.3.2.2 | DCC Test Approach & Plan (PIT) MHHS Review Completed | milestone | 0d | 2023-12-15 A | 2023-12-15 A | 260FS+20d | 100% | 2023-12-15 | 2023-12-15 | 0d | 2023-10-16 | 2023-10-27 |  |  | SI Test | PP | DBT | 5.18 |  | Design, Build & Test (PIT) | Complete | COMPLETE | T3-DB-0115 | SITAG | T3 |  |
| 262 | 1.3.6.3.3.3 | **Test Readiness Report** |  | 22d | 2023-12-04 A | 2024-01-02 A |  | 100% | 2023-12-04 | 2024-01-02 | 51d | 2023-10-27 | 2024-01-05 |  |  | N/A | N/A | DBT | 5.18 | N/A | Design, Build & Test (PIT) |  |  |  |  |  |  |
| 263 | 1.3.6.3.3.3.1 | Test readiness reporting |  | 22d | 2023-12-04 A | 2024-01-02 A | 260FS+10d | 100% | 2023-12-04 | 2024-01-02 | 51d | 2023-10-27 | 2024-01-05 |  |  | PP | 109 | DBT | 5.18 |  | Design, Build & Test (PIT) | Complete | COMPLETE |  |  |  |  |
| 264 | 1.3.6.3.3.4 | **Requirements to test Traceability Matrix (RTTM)** |  | 30d | 2023-12-15 A | 2024-01-26 A |  | 100% | 2023-12-15 | 2024-01-26 | 30d | 2022-10-31 | 2023-11-24 |  | -0 | N/A | N/A | DBT | 5.18 | N/A | Design, Build & Test (PIT) |  |  |  |  |  |  |
| 265 | 1.3.6.3.3.4.1 | DCC RTTM submitted to Programme for assurance | milestone | 0d | 2023-12-15 A | 2023-12-15 A | 260FS+20d | 100% | 2023-12-15 | 2023-12-15 | 0d | 2023-11-10 | 2023-11-10 | start no earlier than 2023-04-28 |  | PP | SI Test | DBT | 5.18 |  | Design, Build & Test (PIT) | Complete | COMPLETE | T3-DB-0074 | SITAG | T3 |  |
| 266 | 1.3.6.3.3.4.2 | DCC RTTM MHHS Review Completed | milestone | 0d | 2024-01-26 A | 2024-01-26 A | 265FS+30d | 100% | 2024-01-26 | 2024-01-26 | 0d | 2023-11-13 | 2023-11-24 |  |  | SI Test | PP | DBT | 5.18 |  | Design, Build & Test (PIT) | Complete | COMPLETE | T3-DB-0116 | SITAG | T3 |  |
| 267 | 1.3.6.3.3.5 | **Test Scenarios** |  | 30d | 2023-12-15 A | 2024-01-26 A |  | 100% | 2023-12-15 | 2024-01-26 | 30d | 2022-10-31 | 2023-11-24 |  | -0 | N/A | N/A | DBT | 5.18 | N/A | Design, Build & Test (PIT) |  |  |  |  |  |  |
| 268 | 1.3.6.3.3.5.1 | DCC test scenarios submitted to Programme for assurance | milestone | 0d | 2023-12-15 A | 2023-12-15 A | 260FS+20d | 100% | 2023-12-15 | 2023-12-15 | 0d | 2023-11-10 | 2023-11-10 |  |  | PP | SI Test | DBT | 5.18 |  | Design, Build & Test (PIT) | Complete | COMPLETE | T3-DB-0078 | SITAG | T3 |  |
| 269 | 1.3.6.3.3.5.2 | DCC Test Scenarios MHHS Review Completed | milestone | 0d | 2024-01-26 A | 2024-01-26 A | 268FS+30d | 100% | 2024-01-26 | 2024-01-26 | 0d | 2023-11-13 | 2023-11-24 |  |  | SI Test | PP | DBT | 5.18 |  | Design, Build & Test (PIT) | Complete | COMPLETE | T3-DB-0117 | SITAG | T3 |  |
| 270 | 1.3.6.3.4 | **RECCo (EES) DBT CIT (Entering at Interval 6)** |  | 71d | 2023-10-13 A | 2024-01-19 A |  | 100% | 2023-10-13 | 2024-01-19 | 320d | 2022-10-31 | 2024-01-05 |  | -0 | N/A | N/A | DBT | 5.0 | N/A | Design, Build & Test (PIT) |  |  |  |  |  |  |
| 271 | 1.3.6.3.4.1 | **Test Approach & Plan** |  | 20d | 2023-10-13 A | 2023-11-09 A |  | 100% | 2023-10-13 | 2023-11-09 | 20d | 2022-10-31 | 2023-10-27 |  | -0 | N/A | N/A | DBT | 5.0 | N/A | Design, Build & Test (PIT) |  |  |  |  |  |  |
| 272 | 1.3.6.3.4.1.1 | EES Test Approach & Plan (PIT) submitted to Programme for assurance | milestone | 0d | 2023-10-13 A | 2023-10-13 A |  | 100% | 2023-10-13 | 2023-10-13 | 0d | 2023-10-13 | 2023-10-13 | start no earlier than 2023-10-13 |  | PP | SI Test | DBT | 5.8 |  | Design, Build & Test (PIT) | Complete | COMPLETE | T3-DB-0066 | SITAG | T3 |  |
| 273 | 1.3.6.3.4.1.2 | EES Test approach and plan (PIT) MHHS Review Completed | milestone | 0d | 2023-11-09 A | 2023-11-09 A | 272FS+20d | 100% | 2023-11-09 | 2023-11-09 | 0d | 2023-10-16 | 2023-10-27 |  |  | SI Test | PP | DBT | 5.8 |  | Design, Build & Test (PIT) | Complete | COMPLETE | T3-DB-0119 | SITAG | T3 |  |
| 274 | 1.3.6.3.4.2 | **Test Readiness Report** |  | 10d | 2023-10-27 A | 2023-11-09 A |  | 100% | 2023-10-27 | 2023-11-09 | 51d | 2023-10-27 | 2024-01-05 |  |  | N/A | N/A | DBT | 5.0 | N/A | Design, Build & Test (PIT) |  |  |  |  |  |  |
| 275 | 1.3.6.3.4.2.1 | Test readiness reporting |  | 10d | 2023-10-27 A | 2023-11-09 A | 272FS+10d | 100% | 2023-10-27 | 2023-11-09 | 51d | 2023-10-27 | 2024-01-05 |  |  | PP | 109 | DBT | 5.0 |  | Design, Build & Test (PIT) | Complete | COMPLETE |  |  |  |  |
| 276 | 1.3.6.3.4.3 | **Requirements to test Traceability Matrix (RTTM)** |  | 20d | 2023-11-02 A | 2023-11-30 A |  | 100% | 2023-11-02 | 2023-11-30 | 20d | 2022-10-31 | 2023-11-24 |  | -0 | N/A | N/A | DBT | 5.0 | N/A | Design, Build & Test (PIT) |  |  |  |  |  |  |
| 277 | 1.3.6.3.4.3.1 | EES RTTM submitted to Programme for assurance | milestone | 0d | 2023-11-02 A | 2023-11-02 A | 272FS+15d | 100% | 2023-11-02 | 2023-11-02 | 0d | 2023-11-10 | 2023-11-10 |  |  | PP | SI Test | DBT | 5.8 |  | Design, Build & Test (PIT) | Complete | COMPLETE | T3-DB-0072 | SITAG | T3 | MHHS-ART009 |
| 278 | 1.3.6.3.4.3.2 | EES RTTM MHHS Review Completed | milestone | 0d | 2023-11-30 A | 2023-11-30 A | 277FS+20d | 100% | 2023-11-30 | 2023-11-30 | 0d | 2023-11-13 | 2023-11-24 |  |  | SI Test | PP | DBT | 5.14 |  | Design, Build & Test (PIT) | Complete | COMPLETE | T3-DB-0120 | SITAG | T3 |  |
| 279 | 1.3.6.3.4.4 | **Test Scenarios** |  | 20d | 2023-11-02 A | 2023-11-30 A |  | 100% | 2023-11-02 | 2023-11-30 | 20d | 2022-10-31 | 2023-11-24 |  | -0 | N/A | N/A | DBT | 5.0 | N/A | Design, Build & Test (PIT) |  |  |  |  |  |  |
| 280 | 1.3.6.3.4.4.1 | EES test scenarios submitted to Programme for assurance | milestone | 0d | 2023-11-02 A | 2023-11-02 A | 272FS+15d | 100% | 2023-11-02 | 2023-11-02 | 0d | 2023-11-10 | 2023-11-10 |  |  | PP | SI Test | DBT | 5.8 |  | Design, Build & Test (PIT) | Complete | COMPLETE | T3-DB-0031 | SITAG | T3 |  |
| 281 | 1.3.6.3.4.4.2 | EES Test scenarios MHHS Review Completed | milestone | 0d | 2023-11-30 A | 2023-11-30 A | 280FS+20d | 100% | 2023-11-30 | 2023-11-30 | 0d | 2023-11-13 | 2023-11-24 |  |  | SI Test | PP | DBT | 5.14 |  | Design, Build & Test (PIT) | Complete | COMPLETE | T3-DB-0121 | SITAG | T3 |  |

| ID | WBS | Task | Type | Duration | Start | Finish | Predecessors | Complete | Remaining | Baseline start | Baseline finish | Baseline duration | Baseline 1 start | Baseline 1 finish | Total slack | Constraint | Baseline cost | Responsible | Involved | Text9 | Update Version | MHHS Resource Name | MHHS Programme Phase | Sched Status | RAG | Milestone ID | Text29 | Tier | Artefact ID |
| --- | --- | --- | --- | --- | --- | --- | --- | --- | --- | --- | --- | --- | --- | --- | --- | --- | --- | --- | --- | --- | --- | --- | --- | --- | --- | --- | --- | --- | --- |
| 282 | 1.3.6.3.4.5 | **PIT execution** |  | 51d | 2023-11-10 A | 2024-01-19 A |  | 100% |  | 2023-11-10 | 2024-01-19 | 320d | 2022-10-31 | 2024-01-05 |  |  | -0 | N/A | N/A | DBT | 5.0 | N/A | Design, Build & Test (PIT) |  |  |  |  |  |  |
| 283 | 1.3.6.3.4.5.1 | PIT Test Execution Progress Report |  | 41d | 2023-11-10 A | 2024-01-05 A | 275 | 100% |  | 2023-11-10 | 2024-01-05 | 41d | 2022-10-31 | 2023-12-29 |  |  |  | PP | SI Test | DBT | 5.0 |  | Design, Build & Test (PIT) | Complete | COMPLETE |  |  |  |  |
| 284 | 1.3.6.3.4.5.2 | PIT Execution |  | 41d | 2023-11-10 A | 2024-01-05 A | 280FS+5d | 100% |  | 2023-11-10 | 2024-01-05 | 310d | 2022-10-31 | 2024-01-05 |  |  |  | PP | SI Test | DBT | 5.0 |  | Design, Build & Test (PIT) | Complete | COMPLETE |  |  |  |  |
| 285 | 1.3.6.3.4.5.3 | EES PIT Completion Report submitted to Programme for assurance | milestone | 0d | 2024-01-05 A | 2024-01-05 A | 283, 284 | 100% |  | 2024-01-05 | 2024-01-05 | 0d | 2024-01-05 | 2024-01-05 |  |  |  | PP | SI Test | DBT | 5.14 |  | Design, Build & Test (PIT) | Complete | COMPLETE | T3-DB-0122 | SITAG | T3 |  |
| 286 | 1.3.6.3.4.5.4 | EES PIT Completion Report MHHS Review Completed | milestone | 0d | 2024-01-19 A | 2024-01-19 A | 273, 278, 281, 285FS+10d | 100% |  | 2024-01-19 | 2024-01-19 | 0d |  |  |  |  |  | SI Test | PP | DBT | 5.14 |  | Design, Build & Test (PIT) | Complete | COMPLETE | T3-DB-0123 | SITAG | T3 |  |
| 287 | 1.3.6.3.5 | **Registration Services DBT CIT (Entering at Interval 2)** |  | 70d | 2023-07-28 A | 2023-11-03 A |  | 100% |  | 2023-07-28 | 2023-11-03 | 70d | 2022-10-31 | 2024-02-28 |  |  | -0 | N/A | N/A | DBT | 5.0 | N/A | Design, Build & Test (PIT) |  |  |  |  |  |  |
| 288 | 1.3.6.3.5.1 | **Test Approach & Plan** |  | 40d | 2023-07-28 A | 2023-09-22 A |  | 100% |  | 2023-07-28 | 2023-09-22 | 40d | 2022-10-31 | 2023-08-11 |  |  | -0 | N/A | N/A | DBT | 5.0 | N/A | Design, Build & Test (PIT) |  |  |  |  |  |  |
| 289 | 1.3.6.3.5.1.1 | Registration Services Test Approach & Plan (PIT) submitted to Programme for assurance | milestone | 0d | 2023-07-28 A | 2023-07-28 A |  | 100% |  | 2023-07-28 | 2023-07-28 | 0d | 2023-07-28 | 2023-07-28 |  |  |  | PP | SI Test | DBT | 5.0 |  | Design, Build & Test (PIT) | Complete | COMPLETE | T3-DB-0028 | SITAG | T3 | MHHS-ART073 |
| 290 | 1.3.6.3.5.1.2 | Registration Services Test approach and plan MHHS Review Completed | milestone | 0d | 2023-09-22 A | 2023-09-22 A | 289FS+40d | 100% |  | 2023-09-22 | 2023-09-22 | 0d | 2023-07-31 | 2023-08-11 |  |  |  | SI Test | PP | DBT | 5.8 |  | Design, Build & Test (PIT) | Complete | COMPLETE | T3-DB-0124 | SITAG | T3 |  |
| 291 | 1.3.6.3.5.2 | **Test Readiness Report** |  | 20d | 2023-08-14 A | 2023-09-08 A |  | 100% |  | 2023-08-14 | 2023-09-08 | 51d | 2023-08-11 | 2023-10-20 |  |  |  | N/A | N/A | DBT | 5.0 | N/A | Design, Build & Test (PIT) |  |  |  |  |  |  |
| 292 | 1.3.6.3.5.2.1 | Test readiness reporting |  | 20d | 2023-08-14 A | 2023-09-08 A | 289FS+10d | 100% |  | 2023-08-14 | 2023-09-08 | 51d | 2023-08-11 | 2023-10-20 |  |  |  | PP | 109 | DBT | 5.0 |  | Design, Build & Test (PIT) | Complete | COMPLETE |  |  |  |  |
| 293 | 1.3.6.3.5.3 | **Requirements to test Traceability Matrix (RTTM)** |  | 20d | 2023-09-01 A | 2023-09-29 A |  | 100% |  | 2023-09-01 | 2023-09-29 | 20d | 2022-10-31 | 2023-09-15 |  |  | -0 | N/A | N/A | DBT | 5.0 | N/A | Design, Build & Test (PIT) |  |  |  |  |  |  |
| 294 | 1.3.6.3.5.3.1 | Registration Services RTTM submitted to Programme for assurance | milestone | 0d | 2023-09-01 A | 2023-09-01 A | 289FS+15d | 100% |  | 2023-09-01 | 2023-09-01 | 0d | 2023-09-01 | 2023-09-01 |  | start no earlier than 2023-04-28 |  | PP | SI Test | DBT | 5.6 |  | Design, Build & Test (PIT) | Complete | COMPLETE | T3-DB-0042 | SITAG | T3 | MHHS-ART009 |
| 295 | 1.3.6.3.5.3.2 | Registration Services RTTM MHHS Review Completed | milestone | 0d | 2023-09-29 A | 2023-09-29 A | 294FS+20d | 100% |  | 2023-09-29 | 2023-09-29 | 0d | 2023-09-04 | 2023-09-15 |  |  |  | SI Test | PP | DBT | 5.8 |  | Design, Build & Test (PIT) | Complete | COMPLETE | T3-DB-0125 | SITAG | T3 |  |
| 296 | 1.3.6.3.5.4 | **Test Scenarios** |  | 20d | 2023-09-01 A | 2023-09-29 A |  | 100% |  | 2023-09-01 | 2023-09-29 | 20d | 2022-10-31 | 2023-09-15 |  |  | -0 | N/A | N/A | DBT | 5.0 | N/A | Design, Build & Test (PIT) |  |  |  |  |  |  |
| 297 | 1.3.6.3.5.4.1 | Registration Services test scenarios submitted to Programme for assurance | milestone | 0d | 2023-09-01 A | 2023-09-01 A | 289FS+15d | 100% |  | 2023-09-01 | 2023-09-01 | 0d | 2023-09-01 | 2023-09-01 |  |  |  | PP | SI Test | DBT | 5.6 |  | Design, Build & Test (PIT) | Complete | COMPLETE | T3-DB-0044 | SITAG | T3 |  |
| 298 | 1.3.6.3.5.4.2 | Registration Services Test scenarios MHHS Review Completed | milestone | 0d | 2023-09-29 A | 2023-09-29 A | 297FS+20d | 100% |  | 2023-09-29 | 2023-09-29 | 0d | 2023-09-04 | 2023-09-15 |  |  |  | SI Test | PP | DBT | 5.8 |  | Design, Build & Test (PIT) | Complete | COMPLETE | T3-DB-0126 | SITAG | T3 |  |
| 299 | 1.3.6.3.5.5 | **PIT execution** |  | 40d | 2023-09-11 A | 2023-11-03 A |  | 100% |  | 2023-09-11 | 2023-11-03 | 40d | 2023-01-02 | 2023-10-20 |  |  | -0 | N/A | N/A | DBT | 5.0 | N/A | Design, Build & Test (PIT) |  |  |  |  |  |  |
| 300 | 1.3.6.3.5.5.1 | PIT Test Execution Progress Report |  | 33d | 2023-09-11 A | 2023-10-25 A | 292 | 100% |  | 2023-09-11 | 2023-10-25 | 30d | 2023-01-02 | 2023-10-13 |  |  |  | PP | SI Test | DBT | 5.0 |  | Design, Build & Test (PIT) | Complete | COMPLETE |  |  |  |  |
| 301 | 1.3.6.3.5.5.2 | PIT Execution |  | 30d | 2023-09-11 A | 2023-10-20 A | 297FS+5d | 100% |  | 2023-09-11 | 2023-10-20 | 30d | 2023-01-16 | 2023-10-20 |  |  |  | PP | SI Test | DBT | 5.0 |  | Design, Build & Test (PIT) | Complete | COMPLETE |  |  |  |  |
| 302 | 1.3.6.3.5.5.3 | Registration Services PIT (CIT interval 2) Completion Report submitted to Programme for assurance | milestone | 0d | 2023-10-25 A | 2023-10-25 A | 300, 301 | 100% |  | 2023-10-25 | 2023-10-25 | 0d | 2024-01-05 | 2024-01-05 |  |  |  | PP | SI Test | DBT | 5.10 |  | Design, Build & Test (PIT) | Complete | COMPLETE | T3-DB-0127 | SITAG | T3 |  |
| 303 | 1.3.6.3.5.5.4 | Registration Services PIT (CIT interval 2) Completion Report MHHS Review Completed | milestone | 0d | 2023-11-03 A | 2023-11-03 A | 290, 295, 298, 302FS+7d | 100% |  | 2023-11-03 | 2023-11-03 | 0d |  |  |  |  |  | SI Test | PP | DBT | 5.11 |  | Design, Build & Test (PIT) | Complete | COMPLETE | T3-DB-0128 | SITAG | T3 |  |
| 304 | 1.3.6.4 | **SIT Participants DBT** |  | 401d | 2023-08-11 A | 2025-02-21 |  | 89% | 43.4d | 2023-08-11 | 2024-12-20 | 495d | 2022-10-31 | 2025-03-14 | 734d |  | -0 | N/A | N/A | DBT | 5.0 | N/A | Design, Build & Test (PIT) |  |  |  |  |  |  |
| 305 | 1.3.6.4.1 | **All Data Services DBT CIT (Entering at Interval 3)** |  | 71d | 2023-08-11 A | 2023-11-17 A |  | 100% |  | 2023-08-11 | 2023-11-17 | 275d | 2022-10-31 | 2023-11-03 |  |  | -0 | N/A | N/A | DBT | 5.0 | N/A | Design, Build & Test (PIT) |  |  |  |  |  |  |
| 306 | 1.3.6.4.1.1 | **Test Approach & Plan** |  | 30d | 2023-08-11 A | 2023-09-21 A |  | 100% |  | 2023-08-11 | 2023-09-21 | 29d | 2022-10-31 | 2023-08-25 |  |  | -0 | N/A | N/A | DBT | 5.0 | N/A | Design, Build & Test (PIT) |  |  |  |  |  |  |
| 307 | 1.3.6.4.1.1.1 | All Data Services Test Approach & Plans (PIT) submitted to Programme for assurance | milestone | 0d | 2023-08-11 A | 2023-08-11 A |  | 100% |  | 2023-08-11 | 2023-08-11 | 0d | 2023-08-11 | 2023-08-11 |  | start no earlier than 2023-08-11 |  | PP | SI Test | DBT | 5.0 |  | Design, Build & Test (PIT) | Complete | COMPLETE | T3-DB-0038 | SITAG | T3 |  |
| 308 | 1.3.6.4.1.1.2 | All Data Services Test approach and plans MHHS Review Completed | milestone | 0d | 2023-09-21 A | 2023-09-21 A | 307FS+30d | 100% |  | 2023-09-21 | 2023-09-21 | 0d | 2023-08-14 | 2023-08-25 |  |  |  | SI Test | PP | DBT | 5.11 |  | Design, Build & Test (PIT) | Complete | COMPLETE | T3-DB-0129 | SITAG | T3 |  |

| ID | WBS | Task | Type | Duration | Start | Finish | Predecessors | Complete | Baseline start | Baseline finish | Baseline duration | Baseline 1 start | Baseline 1 finish | Baseline cost | Responsible | Involved | Text9 | Update Version | MHHS Resource Name | MHHS Programme Phase | Sched Status | RAG | Milestone ID | Text29 | Tier | Artefact ID |
| --- | --- | --- | --- | --- | --- | --- | --- | --- | --- | --- | --- | --- | --- | --- | --- | --- | --- | --- | --- | --- | --- | --- | --- | --- | --- | --- |
| 309 | 1.3.6.4.1.2 | **Test Readiness Report** |  | 11d | 2023-08-25 A | 2023-09-08 A |  | 100% | 2023-08-25 | 2023-09-08 | 11d | 2023-08-25 | 2023-11-03 | -0 | N/A | N/A | DBT | 5.0 | N/A | Design, Build & Test (PIT) |  |  |  |  |  |  |
| 310 | 1.3.6.4.1.2.1 | Test readiness reporting |  | 11d | 2023-08-25 A | 2023-09-08 A | 307FS+10d | 100% | 2023-08-25 | 2023-09-08 | 11d | 2023-08-25 | 2023-11-03 |  | PP | 109 | DBT | 5.0 |  | Design, Build & Test (PIT) | Complete | COMPLETE |  |  |  |  |
| 311 | 1.3.6.4.1.3 | **Requirements to test Traceability Matrix (RTTM)** |  | 7d | 2023-09-20 A | 2023-09-29 A |  | 100% | 2023-09-20 | 2023-09-29 | 5d | 2022-10-31 | 2023-10-06 | -0 | N/A | N/A | DBT | 5.0 | N/A | Design, Build & Test (PIT) |  |  |  |  |  |  |
| 312 | 1.3.6.4.1.3.1 | All Data Services RTTMs submitted to Programme for assurance | milestone | 0d | 2023-09-20 A | 2023-09-20 A | 307FS+29d | 100% | 2023-09-20 | 2023-09-20 | 0d | 2023-09-22 | 2023-09-22 |  | PP | SI Test | DBT | 5.7 |  | Design, Build & Test (PIT) | Complete | COMPLETE | T3-DB-0058 | SITAG | T3 |  |
| 313 | 1.3.6.4.1.3.2 | All Data Services RTTMs MHHS Review Completed | milestone | 0d | 2023-09-29 A | 2023-09-29 A | 312FS+7d | 100% | 2023-09-29 | 2023-09-29 | 0d | 2023-09-25 | 2023-10-06 |  | SI Test | PP | DBT | 5.8 |  | Design, Build & Test (PIT) | Complete | COMPLETE | T3-DB-0130 | SITAG | T3 |  |
| 314 | 1.3.6.4.1.4 | **Test Scenarios** |  | 6d | 2023-09-20 A | 2023-09-28 A |  | 100% | 2023-09-20 | 2023-09-28 | 4d | 2022-10-31 | 2023-10-06 | -0 | N/A | N/A | DBT | 5.0 | N/A | Design, Build & Test (PIT) |  |  |  |  |  |  |
| 315 | 1.3.6.4.1.4.1 | All Data Services test scenarios' submitted to Programme for assurance | milestone | 0d | 2023-09-20 A | 2023-09-20 A | 307FS+29d | 100% | 2023-09-20 | 2023-09-20 | 0d | 2023-09-22 | 2023-09-22 |  | PP | SI Test | DBT | 5.7 |  | Design, Build & Test (PIT) | Complete | COMPLETE | T3-DB-0056 | SITAG | T3 |  |
| 316 | 1.3.6.4.1.4.2 | All Data Services Test scenarios' MHHS Review Completed | milestone | 0d | 2023-09-28 A | 2023-09-28 A | 315FS+6d | 100% | 2023-09-28 | 2023-09-28 | 0d | 2023-09-25 | 2023-10-06 |  | SI Test | PP | DBT | 5.11 |  | Design, Build & Test (PIT) | Complete | COMPLETE | T3-DB-0131 | SITAG | T3 |  |
| 317 | 1.3.6.4.1.5 | **PIT execution** |  | 50d | 2023-09-11 A | 2023-11-17 A |  | 100% | 2023-09-11 | 2023-11-17 | 275d | 2022-10-31 | 2023-11-03 | -0 | N/A | N/A | DBT | 5.0 | N/A | Design, Build & Test (PIT) |  |  |  |  |  |  |
| 318 | 1.3.6.4.1.5.1 | PIT Test Execution Progress Report |  | 40d | 2023-09-11 A | 2023-11-03 A | 310 | 100% | 2023-09-11 | 2023-11-03 | 260d | 2022-10-31 | 2023-10-27 |  | PP | SI Test | DBT | 5.0 |  | Design, Build & Test (PIT) | Complete | COMPLETE |  |  |  |  |
| 319 | 1.3.6.4.1.5.2 | PIT Execution |  | 27d | 2023-09-28 A | 2023-11-03 A | 315FS+5d | 100% | 2023-09-28 | 2023-11-03 | 265d | 2022-10-31 | 2023-11-03 |  | PP | SI Test | DBT | 5.0 |  | Design, Build & Test (PIT) | Complete | COMPLETE |  |  |  |  |
| 320 | 1.3.6.4.1.5.3 | All Data Services PIT Completion Reports submitted to Programme for assurance | milestone | 0d | 2023-11-03 A | 2023-11-03 A | 318, 319 | 100% | 2023-11-03 | 2023-11-03 | 0d | 2024-01-05 | 2024-01-05 |  | PP | SI Test | DBT | 5.11 |  | Design, Build & Test (PIT) | Complete | COMPLETE | T3-DB-0132 | SITAG | T3 |  |
| 321 | 1.3.6.4.1.5.4 | All Data Services PIT Completion Reports MHHS Review Completed | milestone | 0d | 2023-11-17 A | 2023-11-17 A | 308, 313, 316, 320FS+10d | 100% | 2023-11-17 | 2023-11-17 | 0d |  |  |  | SI Test | PP | DBT | 5.13 |  | Design, Build & Test (PIT) | Complete | COMPLETE | T3-DB-0133 | SITAG | T3 |  |
| 322 | 1.3.6.4.2 | **All Metering Services DBT CIT (Entering at Interval 4)** |  | 70d | 2023-08-25 A | 2023-12-01 A |  | 100% | 2023-08-25 | 2023-12-01 | 285d | 2022-10-31 | 2023-11-17 | -0 | N/A | N/A | DBT | 5.0 | N/A | Design, Build & Test (PIT) |  |  |  |  |  |  |
| 323 | 1.3.6.4.2.1 | **Test Approach & Plan** |  | 40d | 2023-08-25 A | 2023-10-20 A |  | 100% | 2023-08-25 | 2023-10-20 | 40d | 2022-10-31 | 2023-09-08 | -0 | N/A | N/A | DBT | 5.0 | N/A | Design, Build & Test (PIT) |  |  |  |  |  |  |
| 324 | 1.3.6.4.2.1.1 | All Metering Services Test Approach & Plans (PIT) submitted to Programme for assurance | milestone | 0d | 2023-08-25 A | 2023-08-25 A |  | 100% | 2023-08-25 | 2023-08-25 | 0d | 2023-08-25 | 2023-08-25 |  | PP | SI Test | DBT | 5.6 |  | Design, Build & Test (PIT) | Complete | COMPLETE | T3-DB-0040 | SITAG | T3 |  |
| 325 | 1.3.6.4.2.1.2 | All Metering Services Test approach and plans MHHS Review Completed | milestone | 0d | 2023-10-20 A | 2023-10-20 A | 324FS+40d | 100% | 2023-10-20 | 2023-10-20 | 0d | 2023-08-28 | 2023-09-08 |  | SI Test | PP | DBT | 5.8 |  | Design, Build & Test (PIT) | Complete | COMPLETE | T3-DB-0134 | SITAG | T3 |  |
| 326 | 1.3.6.4.2.2 | **Test Readiness Report** |  | 11d | 2023-09-11 A | 2023-09-25 A |  | 100% | 2023-09-11 | 2023-09-25 | 51d | 2023-09-08 | 2023-11-17 |  | N/A | N/A | DBT | 5.0 | N/A | Design, Build & Test (PIT) |  |  |  |  |  |  |
| 327 | 1.3.6.4.2.2.1 | Test readiness reporting |  | 11d | 2023-09-11 A | 2023-09-25 A | 324FS+10d | 100% | 2023-09-11 | 2023-09-25 | 51d | 2023-09-08 | 2023-11-17 |  | PP | 109 | DBT | 5.0 |  | Design, Build & Test (PIT) | Complete | COMPLETE |  |  |  |  |
| 328 | 1.3.6.4.2.3 | **Requirements to test Traceability Matrix (RTTM)** |  | 30d | 2023-09-15 A | 2023-10-27 A |  | 100% | 2023-09-15 | 2023-10-27 | 30d | 2022-10-31 | 2023-09-29 | -0 | N/A | N/A | DBT | 5.0 | N/A | Design, Build & Test (PIT) |  |  |  |  |  |  |
| 329 | 1.3.6.4.2.3.1 | All Metering Services RTTMs submitted to Programme for assurance | milestone | 0d | 2023-09-15 A | 2023-09-15 A | 324FS+15d | 100% | 2023-09-15 | 2023-09-15 | 0d | 2023-09-15 | 2023-09-15 |  | PP | SI Test | DBT | 5.8 |  | Design, Build & Test (PIT) | Complete | COMPLETE | T3-DB-0048 | SITAG | T3 | MHHS-ART009 |
| 330 | 1.3.6.4.2.3.2 | All Metering Services MHHS Reviews Completed | milestone | 0d | 2023-10-27 A | 2023-10-27 A | 329FS+30d | 100% | 2023-10-27 | 2023-10-27 | 0d | 2023-09-18 | 2023-09-29 |  | SI Test | PP | DBT | 5.13 |  | Design, Build & Test (PIT) | Complete | COMPLETE | T3-DB-0135 | SITAG | T3 |  |
| 331 | 1.3.6.4.2.4 | **Test Scenarios** |  | 30d | 2023-09-15 A | 2023-10-27 A |  | 100% | 2023-09-15 | 2023-10-27 | 30d | 2022-10-31 | 2023-09-29 | -0 | N/A | N/A | DBT | 5.0 | N/A | Design, Build & Test (PIT) |  |  |  |  |  |  |
| 332 | 1.3.6.4.2.4.1 | All Metering Services test scenarios' submitted to Programme for assurance | milestone | 0d | 2023-09-15 A | 2023-09-15 A | 324FS+15d | 100% | 2023-09-15 | 2023-09-15 | 0d | 2023-09-15 | 2023-09-15 |  | PP | SI Test | DBT | 5.8 |  | Design, Build & Test (PIT) | Complete | COMPLETE | T3-DB-0050 | SITAG | T3 |  |
| 333 | 1.3.6.4.2.4.2 | All Metering Services Test scenarios' MHHS Review Completed | milestone | 0d | 2023-10-27 A | 2023-10-27 A | 332FS+30d | 100% | 2023-10-27 | 2023-10-27 | 0d | 2023-09-18 | 2023-09-29 |  | SI Test | PP | DBT | 5.13 |  | Design, Build & Test (PIT) | Complete | COMPLETE | T3-DB-0136 | SITAG | T3 |  |

| ID | WBS | Task | Type | Duration | Start | Finish | Predecessors | Complete | Remaining | Baseline start | Baseline finish | Baseline duration | Baseline 1 start | Baseline 1 finish | Total slack | Constraint | Baseline cost | Responsible | Involved | Text9 | Update Version | MHHS Resource Name | MHHS Programme Phase | Sched Status | RAG | Milestone ID | Text29 | Tier |
| --- | --- | --- | --- | --- | --- | --- | --- | --- | --- | --- | --- | --- | --- | --- | --- | --- | --- | --- | --- | --- | --- | --- | --- | --- | --- | --- | --- | --- |
| 334 | 1.3.6.4.2.5 | **PIT execution** |  | 50d | 2023-09-25 A | 2023-12-01 A |  | 100% |  | 2023-09-25 | 2023-12-01 | 285d | 2022-10-31 | 2023-11-17 |  |  | -0 | N/A | N/A | DBT | 5.0 | N/A | Design, Build & Test (PIT) |  |  |  |  |  |
| 335 | 1.3.6.4.2.5.1 | PIT Test Execution Progress Report |  | 39d | 2023-09-26 A | 2023-11-17 A | 327 | 100% |  | 2023-09-26 | 2023-11-17 | 39d | 2022-10-31 | 2023-11-10 |  |  |  | PP | SI Test | DBT | 5.0 |  | Design, Build & Test (PIT) | Complete | COMPLETE |  |  |  |
| 336 | 1.3.6.4.2.5.2 | PIT Execution |  | 40d | 2023-09-25 A | 2023-11-17 A | 332FS+5d | 100% |  | 2023-09-25 | 2023-11-17 | 275d | 2022-10-31 | 2023-11-17 |  |  |  | PP | SI Test | DBT | 5.0 |  | Design, Build & Test (PIT) | Complete | COMPLETE |  |  |  |
| 337 | 1.3.6.4.2.5.3 | All Metering Services PIT Completion Reports submitted to Programme for assurance | milestone | 0d | 2023-11-17 A | 2023-11-17 A | 335, 336 | 100% |  | 2023-11-17 | 2023-11-17 | 0d | 2024-01-05 | 2024-01-05 |  |  |  | PP | SI Test | DBT | 5.13 |  | Design, Build & Test (PIT) | Complete | COMPLETE | T3-DB-0137 | SITAG | T3 |
| 338 | 1.3.6.4.2.5.4 | All Metering Services PIT Completion Reports MHHS Review Completed | milestone | 0d | 2023-12-01 A | 2023-12-01 A | 325, 330, 333, 337FS+10d | 100% |  | 2023-12-01 | 2023-12-01 | 0d |  |  |  |  |  | SI Test | PP | DBT | 5.13 |  | Design, Build & Test (PIT) | Complete | COMPLETE | T3-DB-0138 | SITAG | T3 |
| 339 | 1.3.6.4.3 | **All SIT Programme Participants PIT (SIT Functional)** |  | 331d | 2023-11-17 A | 2025-02-21 |  | 77% | 77.15d | 2023-11-17 | 2024-12-20 | 451d | 2022-12-30 | 2024-02-16 | 734d |  | -0 | N/A | N/A | DBT | 5.0 | N/A | Design, Build & Test (PIT) |  |  |  |  |  |
| 340 | 1.3.6.4.3.1 | **Test Approach & Plans** |  | 40d | 2023-11-17 A | 2024-01-11 A |  | 100% |  | 2023-11-17 | 2024-01-11 | 40d | 2022-12-30 | 2023-11-30 |  |  | -0 | N/A | N/A | DBT | 5.2 | N/A | Design, Build & Test (PIT) |  |  |  |  |  |
| 341 | 1.3.6.4.3.1.1 | SIT Functional PIT Test Approach & Plan (PIT) submitted to Programme for assurance | milestone | 0d | 2023-11-17 A | 2023-11-17 A |  | 100% |  | 2023-11-17 | 2023-11-17 | 0d | 2023-11-16 | 2023-11-16 |  | start no earlier than 2023-11-17 |  | PP | SI Test | DBT | 5.16 |  | Design, Build & Test (PIT) | Complete | COMPLETE | T3-DB-0093 | SITAG | T3 |
| 342 | 1.3.6.4.3.1.2 | All SIT Functional Test approach and plans MHHS Reviews Completed | milestone | 0d | 2024-01-11 A | 2024-01-11 A | 341FS+40d | 100% |  | 2024-01-11 | 2024-01-11 | 0d | 2023-11-17 | 2023-11-30 |  |  |  | SI Test | PP | DBT | 5.8 |  | Design, Build & Test (PIT) | Complete | COMPLETE | T3-DB-0139 | SITAG | T3 |
| 343 | 1.3.6.4.3.2 | **Test Readiness Reports** |  | 11d | 2023-12-01 A | 2023-12-15 A |  | 100% |  | 2023-12-01 | 2023-12-15 | 51d | 2023-11-30 | 2024-02-08 |  |  |  | N/A | N/A | DBT | 5.2 | N/A | Design, Build & Test (PIT) |  |  |  |  |  |
| 344 | 1.3.6.4.3.2.1 | Test readiness reporting |  | 11d | 2023-12-01 A | 2023-12-15 A | 341FS+10d | 100% |  | 2023-12-01 | 2023-12-15 | 51d | 2023-11-30 | 2024-02-08 |  |  |  | PP | 109 | DBT | 5.2 |  | Design, Build & Test (PIT) | Complete | COMPLETE |  |  |  |
| 345 | 1.3.6.4.3.3 | **Requirements to test Traceability Matrices (RTTM)** |  | 30d | 2023-12-07 A | 2024-01-18 A |  | 100% |  | 2023-12-07 | 2024-01-18 | 30d | 2023-01-06 | 2024-01-05 |  |  | -0 | N/A | N/A | DBT | 5.2 | N/A | Design, Build & Test (PIT) |  |  |  |  |  |
| 346 | 1.3.6.4.3.3.1 | SIT Functional PIT RTTM submitted to Programme for assurance | milestone | 0d | 2023-12-07 A | 2023-12-07 A | 341FS+15d | 100% |  | 2023-12-07 | 2023-12-07 | 0d | 2023-12-14 | 2023-12-14 |  |  |  | PP | SI Test | DBT | 5.14 |  | Design, Build & Test (PIT) | Complete | COMPLETE | T3-DB-0091 | SITAG | T3 |
| 347 | 1.3.6.4.3.3.2 | All SIT Functional RTTMs MHHS Reviews Completed | milestone | 0d | 2024-01-18 A | 2024-01-18 A | 346FS+30d | 100% |  | 2024-01-18 | 2024-01-18 | 0d | 2023-12-15 | 2024-01-05 |  |  |  | SI Test | PP | DBT | 5.14 |  | Design, Build & Test (PIT) | Complete | COMPLETE | T3-DB-0140 | SITAG | T3 |
| 348 | 1.3.6.4.3.4 | **Test Scenarios** |  | 30d | 2023-12-07 A | 2024-01-18 A |  | 100% |  | 2023-12-07 | 2024-01-18 | 30d | 2023-01-06 | 2024-01-05 |  |  | -0 | N/A | N/A | DBT | 5.2 | N/A | Design, Build & Test (PIT) |  |  |  |  |  |
| 349 | 1.3.6.4.3.4.1 | SIT Functional PIT test scenarios submitted to Programme for assurance | milestone | 0d | 2023-12-07 A | 2023-12-07 A | 341FS+15d | 100% |  | 2023-12-07 | 2023-12-07 | 0d | 2023-12-14 | 2023-12-14 |  |  |  | PP | SI Test | DBT | 5.14 |  | Design, Build & Test (PIT) | Complete | COMPLETE | T3-DB-0089 | SITAG | T3 |
| 350 | 1.3.6.4.3.4.2 | All SIT Functional Test scenarios' MHHS Reviews Completed | milestone | 0d | 2024-01-18 A | 2024-01-18 A | 349FS+30d | 100% |  | 2024-01-18 | 2024-01-18 | 0d | 2023-12-15 | 2024-01-05 |  |  |  | SI Test | PP | DBT | 5.14 |  | Design, Build & Test (PIT) | Complete | COMPLETE | T3-DB-0141 | SITAG | T3 |
| 351 | 1.3.6.4.3.5 | **PIT execution** |  | 51d | 2023-12-15 A | 2024-02-23 A |  | 100% |  | 2023-12-15 | 2024-02-23 | 301d | 2022-12-30 | 2024-02-09 |  |  | -0 | N/A | N/A | DBT | 5.0 | N/A | Design, Build & Test (PIT) |  |  |  |  |  |
| 352 | 1.3.6.4.3.5.1 | PIT Test Execution Progress Reports |  | 40d | 2023-12-18 A | 2024-02-09 A | 344 | 100% |  | 2023-12-18 | 2024-02-09 | 40d | 2022-12-30 | 2024-02-01 |  |  |  | PP | SI Test | DBT | 5.0 |  | Design, Build & Test (PIT) | Complete | COMPLETE |  |  |  |
| 353 | 1.3.6.4.3.5.2 | PIT Execution |  | 41d | 2023-12-15 A | 2024-02-09 A | 349FS+5d | 100% |  | 2023-12-15 | 2024-02-09 | 290d | 2022-12-30 | 2024-02-09 |  |  |  | PP | SI Test | DBT | 5.0 |  | Design, Build & Test (PIT) | Complete | COMPLETE |  |  |  |
| 354 | 1.3.6.4.3.5.3 | All SIT Functional PIT Completion Reports submitted to Programme for Assurance | milestone | 0d | 2024-02-09 A | 2024-02-09 A | 352, 353 | 100% |  | 2024-02-09 | 2024-02-09 | 0d | 2024-01-05 | 2024-01-05 |  |  |  | PP | SI Test | DBT | 5.19 |  | Design, Build & Test (PIT) | Complete | COMPLETE | T3-DB-0087 | SITAG | T3 |
| 355 | 1.3.6.4.3.5.4 | All SIT Functional PIT Completion Reports MHHS Review Completed | milestone | 0d | 2024-02-23 A | 2024-02-23 A | 342, 347, 350, 354FS+10d | 100% |  | 2024-02-23 | 2024-02-23 | 0d |  |  |  |  |  | SI Test | PP | DBT | 5.19 |  | Design, Build & Test (PIT) | Complete | COMPLETE | T3-DB-0142 | SITAG | T3 |
| 356 | 1.3.6.4.3.6 | **All SIT Programme Participants PIT (SIT Migration)** |  | 71d | 2024-02-16 A | 2024-05-24 A |  | 100% |  | 2024-02-16 | 2024-05-24 | 301d |  |  |  |  | -0 | N/A | N/A | DBT | 5.1 | N/A | Design, Build & Test (PIT) |  |  |  |  |  |
| 357 | 1.3.6.4.3.6.1 | **Test Approach & Plans** |  | 40d | 2024-02-16 A | 2024-04-11 A |  | 100% |  | 2024-02-16 | 2024-04-11 | 40d |  |  |  |  | -0 | N/A | N/A | DBT | 5.2 | N/A | Design, Build & Test (PIT) |  |  |  |  |  |
| 358 | 1.3.6.4.3.6.1.1 | All SIT Migration PIT Test Approach & Plans submitted to Programme for assurance | milestone | 0d | 2024-02-16 A | 2024-02-16 A |  | 100% |  | 2024-02-16 | 2024-02-16 | 0d |  |  |  | start no earlier than 2024-02-16 |  | PP | SI Test | DBT | 5.8 |  | Design, Build & Test (PIT) | Complete | COMPLETE | T3-DB-0143 | SITAG | T3 |
| 359 | 1.3.6.4.3.6.1.2 | All SIT Migration PIT Test approach and plans MHHS Reviews Completed | milestone | 0d | 2024-04-11 A | 2024-04-11 A | 358FS+40d | 100% |  | 2024-04-11 | 2024-04-11 | 0d |  |  |  |  |  | SI Test | PP | DBT | 5.23 |  | Design, Build & Test (PIT) | Complete | COMPLETE | T3-DB-0144 | SITAG | T3 |

| ID | WBS | Task | Type | Duration | Start | Finish | Predecessors | Complete | Remaining | Baseline start | Baseline finish | Baseline duration | Baseline 1 start | Baseline 1 finish | Total slack | Free slack | Constraint | Baseline cost | Responsible | Involved | Text9 | Update Version | MHHS Resource Name | MHHS Programme Phase | Sched Status | RAG | Milestone ID | Text29 | Tier | Guidance | Task Status |
| --- | --- | --- | --- | --- | --- | --- | --- | --- | --- | --- | --- | --- | --- | --- | --- | --- | --- | --- | --- | --- | --- | --- | --- | --- | --- | --- | --- | --- | --- | --- | --- |
| 360 | 1.3.6.4.3.6.2 | **Test Readiness Reports** |  | 11d | 2024-03-01 A | 2024-03-15 A |  | 100% |  | 2024-03-01 | 2024-03-15 | 51d |  |  |  |  |  |  | N/A | N/A | DBT | 5.2 | N/A | Design, Build & Test (PIT) |  |  |  |  |  |  |  |
| 361 | 1.3.6.4.3.6.2.1 | Test readiness reporting |  | 11d | 2024-03-01 A | 2024-03-15 A | 358FS+10d | 100% |  | 2024-03-01 | 2024-03-15 | 51d |  |  |  |  |  |  | PP | 109 | DBT | 5.2 |  | Design, Build & Test (PIT) | Complete | COMPLETE |  |  |  |  |  |
| 362 | 1.3.6.4.3.6.3 | **Requirements to test Traceability Matrices (RTTM)** |  | 30d | 2024-03-07 A | 2024-04-18 A |  | 100% |  | 2024-03-07 | 2024-04-18 | 30d |  |  |  |  |  | -0 | N/A | N/A | DBT | 5.2 | N/A | Design, Build & Test (PIT) |  |  |  |  |  |  |  |
| 363 | 1.3.6.4.3.6.3.1 | All SIT Migration PIT RTTMs submitted to Programme for assurance | milestone | 0d | 2024-03-07 A | 2024-03-07 A | 358FS+15d | 100% |  | 2024-03-07 | 2024-03-07 | 0d |  |  |  |  |  |  | PP | SI Test | DBT | 5.23 |  | Design, Build & Test (PIT) | Complete | COMPLETE | T3-DB-0145 | SITAG | T3 |  |  |
| 364 | 1.3.6.4.3.6.3.2 | All SIT Migration RTTMs MHHS Reviews Completed | milestone | 0d | 2024-04-18 A | 2024-04-18 A | 363FS+30d | 100% |  | 2024-04-18 | 2024-04-18 | 0d |  |  |  |  |  |  | SI Test | PP | DBT | 5.25 |  | Design, Build & Test (PIT) | Complete | COMPLETE | T3-DB-0146 | SITAG | T3 |  |  |
| 365 | 1.3.6.4.3.6.4 | **Test Scenarios** |  | 30d | 2024-03-07 A | 2024-04-18 A |  | 100% |  | 2024-03-07 | 2024-04-18 | 30d |  |  |  |  |  | -0 | N/A | N/A | DBT | 5.2 | N/A | Design, Build & Test (PIT) |  |  |  |  |  |  |  |
| 366 | 1.3.6.4.3.6.4.1 | All SIT Migration PIT test scenarios submitted to Programme for assurance | milestone | 0d | 2024-03-07 A | 2024-03-07 A | 358FS+15d | 100% |  | 2024-03-07 | 2024-03-07 | 0d |  |  |  |  |  |  | PP | SI Test | DBT | 5.23 |  | Design, Build & Test (PIT) | Complete | COMPLETE | T3-DB-0147 | SITAG | T3 |  |  |
| 367 | 1.3.6.4.3.6.4.2 | All SIT Migration Test scenarios MHHS Reviews Completed | milestone | 0d | 2024-04-18 A | 2024-04-18 A | 366FS+30d | 100% |  | 2024-04-18 | 2024-04-18 | 0d |  |  |  |  |  |  | SI Test | PP | DBT | 5.25 |  | Design, Build & Test (PIT) | Complete | COMPLETE | T3-DB-0148 | SITAG | T3 |  |  |
| 368 | 1.3.6.4.3.6.5 | **PIT execution** |  | 51d | 2024-03-15 A | 2024-05-24 A |  | 100% |  | 2024-03-15 | 2024-05-24 | 301d |  |  |  |  |  | -0 | N/A | N/A | DBT | 5.1 | N/A | Design, Build & Test (PIT) |  |  |  |  |  |  |  |
| 369 | 1.3.6.4.3.6.5.1 | PIT Test Execution Progress Reports |  | 40d | 2024-03-18 A | 2024-05-10 A | 361 | 100% |  | 2024-03-18 | 2024-05-10 | 40d |  |  |  |  |  |  | PP | SI Test | DBT | 5.1 |  | Design, Build & Test (PIT) | Complete | COMPLETE |  |  |  |  |  |
| 370 | 1.3.6.4.3.6.5.2 | PIT Execution |  | 41d | 2024-03-15 A | 2024-05-10 A | 366FS+5d | 100% |  | 2024-03-15 | 2024-05-10 | 290d |  |  |  |  |  |  | PP | SI Test | DBT | 5.1 |  | Design, Build & Test (PIT) | Complete | COMPLETE |  |  |  |  |  |
| 371 | 1.3.6.4.3.6.5.3 | All SIT Migration PIT Completion Reports submitted to Programme for assurance | milestone | 0d | 2024-05-10 A | 2024-05-10 A | 369, 370 | 100% |  | 2024-05-10 | 2024-05-10 | 0d | 2024-01-05 | 2024-01-05 |  |  |  |  | PP | SI Test | DBT | 5.8 |  | Design, Build & Test (PIT) | Complete | COMPLETE | T3-DB-0149 | SITAG | T3 |  |  |
| 372 | 1.3.6.4.3.6.5.4 | All SIT Migration PIT Completion Reports MHHS Review Completed | milestone | 0d | 2024-05-24 A | 2024-05-24 A | 359, 364, 367, 371FS+10d | 100% |  | 2024-05-24 | 2024-05-24 | 0d |  |  |  |  |  |  | SI Test | PP | DBT | 5.8 |  | Design, Build & Test (PIT) | Complete | COMPLETE | T3-DB-0150 | SITAG | T3 |  |  |
| 373 | 1.3.6.4.3.7 | **All SIT Programme Participants PIT (SIT Non Functional)** |  | 161d | 2024-07-12 A | 2025-02-21 |  | 63% | 59.63d | 2024-07-12 | 2024-12-20 | 301d |  |  | 734d |  |  | -0 | N/A | N/A | DBT | 6.0 | N/A | Design, Build & Test (PIT) |  |  |  |  |  |  |  |
| 374 | 1.3.6.4.3.7.1 | **Test Approach & Plan** |  | 41d | 2024-09-27 A | 2024-11-22 |  |  | 41d | 2024-09-27 | 2024-11-22 | 40d |  |  | 186d |  |  | -0 | N/A | N/A | DBT | 6.0 | N/A | Design, Build & Test (PIT) |  |  |  |  |  |  |  |
| 375 | 1.3.6.4.3.7.1.1 | SIT Non-Functional PIT Test Approach & Plan (PIT) submitted to Programme for assurance | milestone | 0d | 2024-09-27 A | 2024-09-27 |  | 75% | 0d | 2024-09-27 | 2024-09-27 | 0d |  |  | 0d |  | start no earlier than 2024-05-10 |  | PP | SI Test | DBT | 6.0 | Roger Robar | Design, Build & Test (PIT) | Overdue | RED | T3-DB-0151 | SITAG | T3 |  |  |
| 376 | 1.3.6.4.3.7.1.2 | SIT Non-Functional Test approach and plan MHHS Review Completed |  | 1d | 2024-11-21 A | 2024-11-22 | 375FS+40d |  | 1d | 2024-11-21 | 2024-11-22 | 0d |  |  | 186d | 20d |  |  | SI Test | PP | DBT | 6.0 | Roger Robar | Design, Build & Test (PIT) | Green | RED | T3-DB-0152 | SITAG | T3 | 6/9/24: Approved at esitag on 26/7/24 | -5.67 |
| 377 | 1.3.6.4.3.7.2 | **Test Readiness Report** |  | 13d | 2024-10-04 A | 2024-10-22 |  | 85% | 2d | 2024-10-04 | 2024-10-22 | 51d |  |  | 0d |  |  |  | N/A | N/A | DBT | 6.0 | N/A | Design, Build & Test (PIT) |  |  |  |  |  |  |  |
| 378 | 1.3.6.4.3.7.2.1 | Test readiness reporting |  | 13d | 2024-10-04 A | 2024-10-22 | 375FS+10d | 85% | 2d | 2024-10-04 | 2024-10-22 | 51d |  |  | 0d |  |  |  | PP | 109 | DBT | 6.0 |  | Design, Build & Test (PIT) | Green | RED |  |  |  |  |  |
| 379 | 1.3.6.4.3.7.3 | **Requirements to test Traceability Matrix (RTTM)** |  | 20d | 2024-11-01 A | 2024-11-29 |  |  | 20d | 2024-11-01 | 2024-11-29 | 30d |  |  | 181d |  |  | -0 | N/A | N/A | DBT | 6.0 | N/A | Design, Build & Test (PIT) |  |  |  |  |  |  |  |
| 380 | 1.3.6.4.3.7.3.1 | SIT Non-Functional PIT RTTM submitted to Programme for assurance | milestone | 0d | 2024-11-01 A | 2024-11-01 A | 375FS+26d | 100% |  | 2024-11-01 | 2024-11-01 | 0d |  |  |  |  |  |  | PP | SI Test | DBT | 6.0 | Roger Robar | Design, Build & Test (PIT) | Complete | COMPLETE | T3-DB-0153 | SITAG | T3 |  |  |
| 381 | 1.3.6.4.3.7.3.2 | SIT Non-Functional RTTM MHHS Review Completed | milestone | 0d | 2024-11-29 | 2024-11-29 | 380FS+20d |  |  | 2024-11-29 | 2024-11-29 | 0d |  |  | 181d | 15d | start no earlier than 2024-11-29 |  | SI Test | PP | DBT | 6.0 | Roger Robar | Design, Build & Test (PIT) | Green | RED | T3-DB-0154 | SITAG | T3 |  | 2.71 |
| 382 | 1.3.6.4.3.7.4 | **Test Scenarios** |  | 20d | 2024-11-01 | 2024-11-29 |  |  |  | 2024-11-01 | 2024-11-29 | 30d |  |  | 0d |  |  | -0 | N/A | N/A | DBT | 6.0 | N/A | Design, Build & Test (PIT) |  |  |  |  |  |  |  |
| 383 | 1.3.6.4.3.7.4.1 | SIT Non-Functional PIT test scenarios submitted to Programme for assurance | milestone | 0d | 2024-11-01 | 2024-11-01 | 375FS+26d |  |  | 2024-11-01 | 2024-11-01 | 0d |  |  | 0d |  |  |  | PP | SI Test | DBT | 6.0 | Roger Robar | Design, Build & Test (PIT) | Green | RED | T3-DB-0155 | SITAG | T3 |  | -25.29 |
| 384 | 1.3.6.4.3.7.4.2 | SIT Non-Functional Test scenarios MHHS Review Completed | milestone | 0d | 2024-11-29 | 2024-11-29 | 383FS+20d |  |  | 2024-11-29 | 2024-11-29 | 0d |  |  | 181d | 15d |  |  | SI Test | PP | DBT | 6.0 | Roger Robar | Design, Build & Test (PIT) | Green | RED | T3-DB-0156 | SITAG | T3 |  | 2.71 |

Notes:
- 375: 20/11/24 - 34/34 initial plans have been submitted to the Programme, but still expecting revised plans from some PPs to address feedback given from the Programme, hence why this activity can't be completed yet.
- 376: 20/11/24 - 14/34 test approach reviews completed. RAG'd red because these reviews won't be complete by the baseline finish date.
- 380: 20/11/24 - 34/34 PPs have submitted RTTMs to the Programme. Assurance is still ongoing.
- 381: 27/11/24 -17/34 RTTMs reviews complete. Status red because Programme is still expecting responses to feedback from some PPs on PIT RTTMs and understands some of these will not be recieved by the 29/11/24 deadline.
- 383: 27/11/24 - 33/34 test scenarios have been submitted to the Programme. But still expecting responses to Programme feedback from some PPs, hence why this activity can't be completed yet.
- 384: 27/11/24 - 18/34 scenarios have been completed. Status red because Programme is still expecting responses to feedback from some PPs on PIT test scenarios, hence why this activity can't be completed yet.

| ID | WBS | Task | Type | Duration | Start | Finish | Predecessors | Complete | Remaining | Baseline start | Baseline finish | Baseline duration | Baseline 1 start | Baseline 1 finish | Total slack | Free slack | Constraint | Baseline cost | Responsible | Involved | Text9 | Update Version | MHHS Resource Name | MHHS Programme Phase | Sched Status | RAG | Task Status | Milestone ID | Text29 | Tier |
| --- | --- | --- | --- | --- | --- | --- | --- | --- | --- | --- | --- | --- | --- | --- | --- | --- | --- | --- | --- | --- | --- | --- | --- | --- | --- | --- | --- | --- | --- | --- |
| 385 | 1.3.6.4.3.7.5 | **PIT execution** |  | 161d | 2024-07-12 A | 2025-02-21 |  | 61% | 63.37d | 2024-07-12 | 2024-12-20 | 301d |  |  | 734d |  |  | -0 | N/A | N/A | DBT | 6.0 | N/A | Design, Build & Test (PIT) |  |  |  |  |  |  |
| 386 | 1.3.6.4.3.7.5.1 | PIT Test Execution Progress Report |  | 50d | 2024-07-15 A | 2024-11-21 | 378 | 56% | 22d | 2024-07-15 | 2024-11-21 | 39d |  |  | 172d | 6d | finish no earlier than 2024-11-21 |  | PP | SI Test | DBT | 6.0 | Roger Robar | Design, Build & Test (PIT) | Green | RED |  |  |  |  |
| 387 | 1.3.6.4.3.7.5.2 | PIT Execution |  | 44d | 2024-07-12 A | 2024-11-29 | 383FS+5d | 66% | 15d | 2024-07-12 | 2024-11-29 | 290d |  |  | 166d | 0d | finish no earlier than 2024-11-29 |  | PP | SI Test | DBT | 6.0 | Roger Robar | Design, Build & Test (PIT) | Green | RED |  |  |  |  |
| 388 | 1.3.6.4.3.7.5.3 | SIT Non-Functional PIT Completion Report submitted to Programme for assurance | milestone | 0d | 2024-11-29 | 2024-11-29 | 386, 387 |  |  | 2024-11-29 | 2024-11-29 | 0d | 2024-01-05 | 2024-01-05 | 166d | 0d |  |  | PP | SI Test | DBT | 6.0 | Roger Robar | Design, Build & Test (PIT) | Green | RED | 2.71 | T3-DB-0157 | SITAG | T3 |
| 389 | 1.3.6.4.3.7.5.4 | SIT Non-Functional PIT Completion Report Theme 1 MHHS Review Completed | milestone | 0d | 2024-12-20 | 2024-12-20 | 376, 381, 384, 388FS+15d |  |  | 2024-12-20 | 2024-12-20 | 0d |  |  | 166d | 15d |  |  | SI Test | PP | DBT | 6.0 | Roger Robar | Design, Build & Test (PIT) | Green | GREEN | 23.71 | T3-DB-0158 | SITAG | T3 |
| 390 | 1.3.6.4.3.7.5.5 | SIT Non-Functional PIT Completion Report Theme 2 & 3 MHHS Review Completed | milestone | 0d | 2025-02-21 | 2025-02-21 | 376, 381, 384, 388FS+60d |  |  |  |  |  |  |  | 734d | 0d |  |  |  |  | DBT | 6.13 |  |  | No BL | GREEN | 86.71 | T3-DB-0186 |  |  |
| 391 | 1.3.6.4.3.8 | **All SIT Programme Participants PIT (SIT Operational)** |  | 116d | 2024-07-12 A | 2024-12-20 |  | 46% | 62.41d | 2024-07-12 | 2024-12-20 | 71d |  |  | 88d |  |  | -0 | N/A | N/A | DBT | 6.0 | N/A | Design, Build & Test (PIT) |  |  |  |  |  |  |
| 392 | 1.3.6.4.3.8.1 | **Test Approach & Plan** |  | 40d | 2024-09-27 | 2024-11-21 |  |  |  | 2024-09-27 | 2024-11-21 | 40d |  |  | 0d |  |  | -0 | N/A | N/A | DBT | 6.0 | N/A | Design, Build & Test (PIT) |  |  |  |  |  |  |
| 393 | 1.3.6.4.3.8.1.1 | SIT Operational PIT Test Approach & Plan (PIT) submitted to Programme for assurance | milestone | 0d | 2024-09-27 | 2024-09-27 |  |  |  | 2024-09-27 | 2024-09-27 | 0d |  |  | 0d |  | start no earlier than 2024-09-27 |  | PP | SI Test | DBT | 6.0 | Roger Robar | Design, Build & Test (PIT) | Overdue Start | RED | -60.67 | T3-DB-0159 | SITAG | T3 |
| 394 | 1.3.6.4.3.8.1.2 | SIT Operational Test approach and plan MHHS Review Completed | milestone | 0d | 2024-11-21 | 2024-11-21 | 393FS+40d |  |  | 2024-11-21 | 2024-11-21 | 0d |  |  | 109d | 21d |  |  | SI Test | PP | DBT | 6.0 | Roger Robar | Design, Build & Test (PIT) | Green | RED | -5.29 | T3-DB-0160 | SITAG | T3 |
| 395 | 1.3.6.4.3.8.2 | **Test Readiness Report** |  | 13d | 2024-10-04 A | 2024-10-22 |  | 42% | 7.5d | 2024-10-04 | 2024-10-22 | 51d |  |  | 0d |  |  |  | N/A | N/A | DBT | 6.0 | N/A | Design, Build & Test (PIT) |  |  |  |  |  |  |
| 396 | 1.3.6.4.3.8.2.1 | Test readiness reporting |  | 13d | 2024-10-04 A | 2024-10-22 | 393FS+10d | 42% | 7.5d | 2024-10-04 | 2024-10-22 | 51d |  |  | 0d |  |  |  | PP | 109 | DBT | 6.0 |  | Design, Build & Test (PIT) | Green | RED |  |  |  |  |
| 397 | 1.3.6.4.3.8.3 | **Requirements to test Traceability Matrix (RTTM)** |  | 20d | 2024-11-01 | 2024-11-29 |  |  |  | 2024-11-01 | 2024-11-29 | 30d |  |  | 103d |  |  | -0 | N/A | N/A | DBT | 6.0 | N/A | Design, Build & Test (PIT) |  |  |  |  |  |  |
| 398 | 1.3.6.4.3.8.3.1 | SIT Operational PIT RTTM submitted to Programme for assurance | milestone | 0d | 2024-11-01 | 2024-11-01 | 393FS+26d |  |  | 2024-11-01 | 2024-11-01 | 0d |  |  | 103d | 0d |  |  | PP | SI Test | DBT | 6.0 | Roger Robar | Design, Build & Test (PIT) | Green | RED | -25.29 | T3-DB-0161 | SITAG | T3 |
| 399 | 1.3.6.4.3.8.3.2 | SIT Operational RTTM MHHS Review Completed | milestone | 0d | 2024-11-29 | 2024-11-29 | 398FS+20d |  |  | 2024-11-29 | 2024-11-29 | 0d |  |  | 103d | 15d |  |  | SI Test | PP | DBT | 6.0 | Roger Robar | Design, Build & Test (PIT) | Green | RED | 2.71 | T3-DB-0162 | SITAG | T3 |
| 400 | 1.3.6.4.3.8.4 | **Test Scenarios** |  | 20d | 2024-11-01 | 2024-11-29 |  |  |  | 2024-11-01 | 2024-11-29 | 30d |  |  | 0d |  |  | -0 | N/A | N/A | DBT | 6.0 | N/A | Design, Build & Test (PIT) |  |  |  |  |  |  |
| 401 | 1.3.6.4.3.8.4.1 | SIT Operational PIT test scenarios submitted to Programme for assurance | milestone | 0d | 2024-11-01 | 2024-11-01 | 393FS+26d |  |  | 2024-11-01 | 2024-11-01 | 0d |  |  | 0d |  |  |  | PP | SI Test | DBT | 6.0 | Roger Robar | Design, Build & Test (PIT) | Green | RED | -25.29 | T3-DB-0163 | SITAG | T3 |
| 402 | 1.3.6.4.3.8.4.2 | SIT Operational Test scenarios MHHS Review Completed | milestone | 0d | 2024-11-29 | 2024-11-29 | 401FS+20d |  |  | 2024-11-29 | 2024-11-29 | 0d |  |  | 103d | 15d |  |  | SI Test | PP | DBT | 6.0 | Roger Robar | Design, Build & Test (PIT) | Green | RED | 2.71 | T3-DB-0164 | SITAG | T3 |
| 403 | 1.3.6.4.3.8.5 | **PIT execution** |  | 116d | 2024-07-12 A | 2024-12-20 |  | 47% | 61.67d | 2024-07-12 | 2024-12-20 | 51d |  |  | 88d |  |  | -0 | N/A | N/A | DBT | 6.0 | N/A | Design, Build & Test (PIT) |  |  |  |  |  |  |
| 404 | 1.3.6.4.3.8.5.1 | PIT Test Execution Progress Report |  | 40d | 2024-07-15 A | 2024-11-21 | 396 | 45% | 22d | 2024-07-15 | 2024-11-21 | 40d |  |  | 94d | 6d |  |  | PP | SI Test | DBT | 6.0 | Roger Robar | Design, Build & Test (PIT) | Green | GREEN |  |  |  |  |
| 405 | 1.3.6.4.3.8.5.2 | PIT Execution |  | 39d | 2024-07-12 A | 2024-11-29 | 401 | 49% | 20d | 2024-07-12 | 2024-11-29 | 41d |  |  | 88d | 0d |  |  | PP | SI Test | DBT | 6.0 | Roger Robar | Design, Build & Test (PIT) | Green | GREEN |  |  |  |  |
| 406 | 1.3.6.4.3.8.5.3 | SIT Operational PIT Completion Report submitted to Programme for assurance | milestone | 0d | 2024-11-29 | 2024-11-29 | 404, 405 |  |  | 2024-11-29 | 2024-11-29 | 0d | 2024-01-05 | 2024-01-05 | 88d | 0d |  |  | PP | SI Test | DBT | 6.0 | Roger Robar | Design, Build & Test (PIT) | Green | RED | 2.71 | T3-DB-0165 | SITAG | T3 |
| 407 | 1.3.6.4.3.8.5.4 | SIT Operational PIT Completion Report MHHS Review Completed | milestone | 0d | 2024-12-20 | 2024-12-20 | 394, 399, 402, 406FS+15d |  |  | 2024-12-20 | 2024-12-20 | 0d |  |  | 88d | 0d |  |  | SI Test | PP | DBT | 6.0 | Roger Robar | Design, Build & Test (PIT) | Green | AMBER | 23.71 | T3-DB-0166 | SITAG | T3 |
| 408 | 1.3.6.4.4 | **All Suppliers DBT CIT (Entering at Interval 5)** |  | 71d | 2023-09-15 A | 2023-12-22 A |  | 100% |  | 2023-09-15 | 2023-12-22 | 300d | 2022-10-31 | 2025-03-14 |  |  |  | -0 | N/A | N/A | DBT | 6.0 | N/A | Design, Build & Test (PIT) |  |  |  |  |  |  |
| 409 | 1.3.6.4.4.1 | **Test Approach & Plan** |  | 20d | 2023-09-15 A | 2023-10-12 A |  | 100% |  | 2023-09-15 | 2023-10-12 | 19d | 2022-10-31 | 2023-09-29 |  |  |  | -0 | N/A | N/A | DBT | 6.0 | N/A | Design, Build & Test (PIT) |  |  |  |  |  |  |
| 410 | 1.3.6.4.4.1.1 | All SIT Suppliers Test Approach & Plans (PIT) submitted to Programme for assurance | milestone | 0d | 2023-09-15 A | 2023-09-15 A |  | 100% |  | 2023-09-15 | 2023-09-15 | 0d | 2023-09-15 | 2023-09-15 |  |  | start no earlier than 2023-09-15 |  | PP | SI Test | DBT | 6.0 |  | Design, Build & Test (PIT) | Complete | COMPLETE |  | T3-DB-0046 | SITAG | T3 |
| 411 | 1.3.6.4.4.1.2 | All SIT Suppliers Test Approach & Plans MHHS Review Completed | milestone | 0d | 2023-10-12 A | 2023-10-12 A | 410FS+20d | 100% |  | 2023-10-12 | 2023-10-12 | 0d | 2023-09-18 | 2023-09-29 |  |  |  |  | SI Test | PP | DBT | 6.0 |  | Design, Build & Test (PIT) | Complete | COMPLETE |  | T3-DB-0167 | SITAG | T3 |

Notes:
- 388: 20/11/24 - 27/34 SIT Non-Functional PIT Completion Reports have been submitted to the Programme. Status red because not all PIT Completion Reports will be recieved by the baseline finish.
- 389: 27/11/24 - 0/2 Theme 1 Completion Reports assured by the Programme. Status green because the deadline for assurance is 20/12/24, as agreed at NFTWG.
- 390: 27/11/24 - 4/34 Theme 2 & 3 Completion Reports assured by the Programme. Status green because the deadline for assurance is 21/02/24, as agreed at NFTWG.
- 393: 27/11/24 - 32/34 test approach and plans have been submitted to the Programme. Status red because not all Test Approaches and Plan have been submitted and reviewed by baseline deadline.
- 394: 27/11/24 - 19/34 reviewed. Status red because not all PIT test approach and plans will be recieved by the baseline finish.
- 398: 27/11/24 - 32/34 SIT Operational PIT RTTMs have been submitted to the Programme. Status red because not all RTTMs have been submitted and reviewed by baseline deadline.
- 399: 27/11/24 - 19/34 reviewed. RAG is red because velocity of RTTM returns by PPs means all reviews won't be completed in time for the baseline finish.
- 401: 27/11/24 - 32/34 SIT Operational PIT test scenarios have been submitted to the Programme. RAG is red because velocity of returns by PPs means all submission won't be recieved in time for the baseline finish.
- 402: 27/11/24 - 13/34 reviewed. RAG is red because velocity of test scenario returns by PPs means all reviews won't be completed in time for the baseline finish.
- 406: 27/11/24 - 11/34 submitted. RAG is red because velocity of PIT Completion Report submissions by PPs means all reviews won't be completed in time for the baseline finish.
- 407: 27/11/24 - 0/34 submitted. RAG is Amber because velocity of submissions by PPs means all reviews might not be completed in time for the deadline.

| ID | WBS | Task | Type | Duration | Start | Finish | Predecessors | Complete | Baseline start | Baseline finish | Baseline duration | Baseline 1 start | Baseline 1 finish | Constraint | Baseline cost | Responsible | Involved | Text9 | Update Version | MHHS Resource Name | MHHS Programme Phase | Sched Status | RAG | Artefact ID | Milestone ID | Text29 | Tier |
| --- | --- | --- | --- | --- | --- | --- | --- | --- | --- | --- | --- | --- | --- | --- | --- | --- | --- | --- | --- | --- | --- | --- | --- | --- | --- | --- | --- |
| 412 | 1.3.6.4.4.2 | **Test Readiness Report** |  | 11d | 2023-09-29 A | 2023-10-13 A |  | 100% | 2023-09-29 | 2023-10-13 | 51d | 2023-09-29 | 2023-12-08 |  |  | N/A | N/A | DBT | 6.0 | N/A | Design, Build & Test (PIT) |  |  |  |  |  |  |
| 413 | 1.3.6.4.4.2.1 | Test readiness reporting |  | 11d | 2023-09-29 A | 2023-10-13 A | 410FS+10d | 100% | 2023-09-29 | 2023-10-13 | 51d | 2023-09-29 | 2023-12-08 |  |  | PP | 109 | DBT | 6.0 |  | Design, Build & Test (PIT) | Complete | COMPLETE |  |  |  |  |
| 414 | 1.3.6.4.4.3 | **Requirements to test Traceability Matrix (RTTM)** |  | 20d | 2023-10-06 A | 2023-11-03 A |  | 100% | 2023-10-06 | 2023-11-03 | 21d | 2022-10-31 | 2023-10-20 |  | -0 | N/A | N/A | DBT | 6.0 | N/A | Design, Build & Test (PIT) |  |  |  |  |  |  |
| 415 | 1.3.6.4.4.3.1 | All SIT Suppliers RTTMs submitted to Programme for assurance | milestone | 0d | 2023-10-06 A | 2023-10-06 A | 410FS+16d | 100% | 2023-10-06 | 2023-10-06 | 1d | 2023-10-06 | 2023-10-06 |  |  | PP | SI Test | DBT | 6.0 |  | Design, Build & Test (PIT) | Complete | COMPLETE | MHHS-ART009 | T3-DB-0064 | SITAG | T3 |
| 416 | 1.3.6.4.4.3.2 | All SIT Suppliers RTTMs MHHS Review Completed | milestone | 0d | 2023-11-03 A | 2023-11-03 A | 415FS+20d | 100% | 2023-11-03 | 2023-11-03 | 0d | 2023-10-09 | 2023-10-20 |  |  | SI Test | PP | DBT | 6.0 |  | Design, Build & Test (PIT) | Complete | COMPLETE |  | T3-DB-0168 | SITAG | T3 |
| 417 | 1.3.6.4.4.4 | **Test Scenarios** |  | 20d | 2023-10-05 A | 2023-11-02 A |  | 100% | 2023-10-05 | 2023-11-02 | 20d | 2022-10-31 | 2023-10-20 |  | -0 | N/A | N/A | DBT | 6.0 | N/A | Design, Build & Test (PIT) |  |  |  |  |  |  |
| 418 | 1.3.6.4.4.4.1 | All SIT Suppliers test scenarios' submitted to Programme for assurance | milestone | 0d | 2023-10-05 A | 2023-10-05 A | 410FS+15d | 100% | 2023-10-05 | 2023-10-05 | 0d | 2023-10-06 | 2023-10-06 |  |  | PP | SI Test | DBT | 6.0 |  | Design, Build & Test (PIT) | Complete | COMPLETE |  | T3-DB-0037 | SITAG | T3 |
| 419 | 1.3.6.4.4.4.2 | All SIT Suppliers Test scenarios' MHHS Review Completed | milestone | 0d | 2023-11-02 A | 2023-11-02 A | 418FS+20d | 100% | 2023-11-02 | 2023-11-02 | 0d | 2023-10-09 | 2023-10-20 |  |  | SI Test | PP | DBT | 6.0 |  | Design, Build & Test (PIT) | Complete | COMPLETE |  | T3-DB-0169 | SITAG | T3 |
| 420 | 1.3.6.4.4.5 | **PIT execution** |  | 51d | 2023-10-13 A | 2023-12-22 A |  | 100% | 2023-10-13 | 2023-12-22 | 300d | 2022-10-31 | 2023-12-08 |  | -0 | N/A | N/A | DBT | 6.0 | N/A | Design, Build & Test (PIT) |  |  |  |  |  |  |
| 421 | 1.3.6.4.4.5.1 | PIT Test Execution Progress Report |  | 40d | 2023-10-16 A | 2023-12-08 A | 418FS+5d, 413 | 100% | 2023-10-16 | 2023-12-08 | 40d | 2022-10-31 | 2023-12-01 |  |  | PP | SI Test | DBT | 6.0 |  | Design, Build & Test (PIT) | Complete | COMPLETE |  |  |  |  |
| 422 | 1.3.6.4.4.5.2 | PIT Execution |  | 41d | 2023-10-13 A | 2023-12-08 A | 418FS+5d | 100% | 2023-10-13 | 2023-12-08 | 290d | 2022-10-31 | 2023-12-08 |  |  | PP | SI Test | DBT | 6.0 |  | Design, Build & Test (PIT) | Complete | COMPLETE |  |  |  |  |
| 423 | 1.3.6.4.4.5.3 | All SIT Suppliers PIT Completion Reports submitted to Programme for assurance | milestone | 0d | 2023-12-08 A | 2023-12-08 A | 422, 421 | 100% | 2023-12-08 | 2023-12-08 | 0d | 2024-01-05 | 2024-01-05 |  |  | PP | SI Test | DBT | 6.0 |  | Design, Build & Test (PIT) | Complete | COMPLETE |  | T3-DB-0170 | SITAG | T3 |
| 424 | 1.3.6.4.4.5.4 | All SIT Suppliers PIT Completion Reports MHHS Review Completed | milestone | 0d | 2023-12-22 A | 2023-12-22 A | 423FS+10d, 411, 416, 419 | 100% | 2023-12-22 | 2023-12-22 | 0d |  |  |  |  | SI Test | PP | DBT | 6.0 |  | Design, Build & Test (PIT) | Complete | COMPLETE |  | T3-DB-0171 | SITAG | T3 |
| 425 | 1.3.6.4.5 | **All LDSO Network Operations DBT CIT (Entering at Interval 5)** |  | 71d | 2023-09-15 A | 2023-12-22 A |  | 100% | 2023-09-15 | 2023-12-22 | 310d | 2022-10-31 | 2025-03-14 |  | -0 | N/A | N/A | DBT | 5.0 | N/A | Design, Build & Test (PIT) |  |  |  |  |  |  |
| 426 | 1.3.6.4.5.1 | **Test Approach & Plan** |  | 71d | 2023-09-15 A | 2023-12-22 A |  | 100% | 2023-09-15 | 2023-12-22 | 310d | 2022-10-31 | 2023-08-11 |  | -0 | N/A | N/A | DBT | 5.0 | N/A | Design, Build & Test (PIT) |  |  |  |  |  |  |
| 427 | 1.3.6.4.5.1.1 | All Network Operation Test Approach & Plans (PIT) submitted to Programme for assurance | milestone | 0d | 2023-09-15 A | 2023-09-15 A |  | 100% | 2023-09-15 | 2023-09-15 | 0d | 2023-07-28 | 2023-07-28 | start no earlier than 2023-09-15 |  | PP | SI Test | DBT | 5.8 |  | Design, Build & Test (PIT) | Complete | COMPLETE |  | T3-DB-0054 | SITAG | T3 |
| 428 | 1.3.6.4.5.1.2 | All Network Operation Test Approach & Plans MHHS Review Completed | milestone | 0d | 2023-10-12 A | 2023-10-12 A | 427FS+20d | 100% | 2023-10-12 | 2023-10-12 | 0d | 2023-07-31 | 2023-08-11 |  |  | SI Test | PP | DBT | 5.8 |  | Design, Build & Test (PIT) | Complete | COMPLETE |  | T3-DB-0172 | SITAG | T3 |
| 429 | 1.3.6.4.5.1.3 | **Test Readiness Report** |  | 11d | 2023-09-29 A | 2023-10-13 A |  | 100% | 2023-09-29 | 2023-10-13 | 51d | 2023-08-11 | 2023-10-20 |  |  | N/A | N/A | DBT | 5.0 | N/A | Design, Build & Test (PIT) |  |  |  |  |  |  |
| 430 | 1.3.6.4.5.1.3.1 | Test readiness reporting |  | 11d | 2023-09-29 A | 2023-10-13 A | 427FS+10d | 100% | 2023-09-29 | 2023-10-13 | 51d | 2023-08-11 | 2023-10-20 |  |  | PP | 109 | DBT | 5.0 |  | Design, Build & Test (PIT) | Complete | COMPLETE |  |  |  |  |
| 431 | 1.3.6.4.5.1.4 | **Requirements to test Traceability Matrix (RTTM)** |  | 20d | 2023-10-05 A | 2023-11-02 A |  | 100% | 2023-10-05 | 2023-11-02 | 20d | 2022-10-31 | 2023-09-15 |  | -0 | N/A | N/A | DBT | 5.0 | N/A | Design, Build & Test (PIT) |  |  |  |  |  |  |
| 432 | 1.3.6.4.5.1.4.1 | All Network Operation RTTMs submitted to Programme for assurance | milestone | 0d | 2023-10-05 A | 2023-10-05 A | 427FS+15d | 100% | 2023-10-05 | 2023-10-05 | 0d | 2023-09-01 | 2023-09-01 | start no earlier than 2023-04-28 |  | PP | SI Test | DBT | 5.8 |  | Design, Build & Test (PIT) | Complete | COMPLETE | MHHS-ART009 | T3-DB-0062 | SITAG | T3 |
| 433 | 1.3.6.4.5.1.4.2 | All Network Operation RTTMs MHHS Review Completed | milestone | 0d | 2023-11-02 A | 2023-11-02 A | 432FS+20d | 100% | 2023-11-02 | 2023-11-02 | 0d | 2023-09-04 | 2023-09-15 |  |  | SI Test | PP | DBT | 5.14 |  | Design, Build & Test (PIT) | Complete | COMPLETE |  | T3-DB-0173 | SITAG | T3 |
| 434 | 1.3.6.4.5.1.5 | **Test Scenarios** |  | 20d | 2023-10-05 A | 2023-11-02 A |  | 100% | 2023-10-05 | 2023-11-02 | 20d | 2022-10-31 | 2023-09-15 |  | -0 | N/A | N/A | DBT | 5.0 | N/A | Design, Build & Test (PIT) |  |  |  |  |  |  |
| 435 | 1.3.6.4.5.1.5.1 | All Network Operation test scenarios' submitted to Programme for assurance | milestone | 0d | 2023-10-05 A | 2023-10-05 A | 427FS+15d | 100% | 2023-10-05 | 2023-10-05 | 0d | 2023-09-01 | 2023-09-01 |  |  | PP | SI Test | DBT | 5.8 |  | Design, Build & Test (PIT) | Complete | COMPLETE |  | T3-DB-0011 | SITAG | T3 |
| 436 | 1.3.6.4.5.1.5.2 | All Network Operation test scenarios' MHHS Review Completed | milestone | 0d | 2023-11-02 A | 2023-11-02 A | 435FS+20d | 100% | 2023-11-02 | 2023-11-02 | 0d | 2023-09-04 | 2023-09-15 |  |  | SI Test | PP | DBT | 5.14 |  | Design, Build & Test (PIT) | Complete | COMPLETE |  | T3-DB-0174 | SITAG | T3 |

| ID | WBS | Task | Type | Duration | Start | Finish | Predecessors | Complete | Remaining | Actual start | Actual finish | Baseline start | Baseline finish | Baseline duration | Baseline 1 start | Baseline 1 finish | Total slack | Constraint | Baseline cost | Responsible | Involved | Text9 | Update Version | MHHS Resource Name | MHHS Programme Phase | Sched Status | RAG | Milestone ID | Text29 | Tier | Artefact ID | Task Status |
| --- | --- | --- | --- | --- | --- | --- | --- | --- | --- | --- | --- | --- | --- | --- | --- | --- | --- | --- | --- | --- | --- | --- | --- | --- | --- | --- | --- | --- | --- | --- | --- | --- |
| 437 | 1.3.6.4.5.1.6 | **PIT execution** |  | 51d | 2023-10-13 A | 2023-12-22 A |  | 100% |  |  |  | 2023-10-13 | 2023-12-22 | 310d | 2022-10-31 | 2024-01-05 |  |  | -0 | N/A | N/A | DBT | 5.0 | N/A | Design, Build & Test (PIT) |  |  |  |  |  |  |  |
| 438 | 1.3.6.4.5.1.6.1 | PIT Test Execution Progress Report |  | 40d | 2023-10-16 A | 2023-12-08 A | 435FS+5d, 430 | 100% |  |  |  | 2023-10-16 | 2023-12-08 | 305d | 2022-10-31 | 2023-12-29 |  |  |  | PP | SI Test | DBT | 5.0 |  | Design, Build & Test (PIT) | Complete | COMPLETE |  |  |  |  |  |
| 439 | 1.3.6.4.5.1.6.2 | PIT Execution |  | 41d | 2023-10-13 A | 2023-12-08 A | 435FS+5d | 100% |  |  |  | 2023-10-13 | 2023-12-08 | 310d | 2022-10-31 | 2024-01-05 |  |  |  | PP | SI Test | DBT | 5.0 |  | Design, Build & Test (PIT) | Complete | COMPLETE |  |  |  |  |  |
| 440 | 1.3.6.4.5.1.6.3 | All Network Operation PIT (CIT interval 5) Completion Reports submitted to Programme for assurance | milestone | 0d | 2023-12-08 A | 2023-12-08 A | 439, 438 | 100% |  |  |  | 2023-12-08 | 2023-12-08 | 0d | 2024-01-05 | 2024-01-05 |  |  |  | PP | SI Test | DBT | 5.0 |  | Design, Build & Test (PIT) | Complete | COMPLETE | T3-DB-0175 | SITAG | T3 |  |  |
| 441 | 1.3.6.4.5.1.6.4 | All Network Operation PIT (CIT interval 5) Completion Reports MHHS Review Completed | milestone | 0d | 2023-12-22 A | 2023-12-22 A | 440FS+10d, 428, 433, 436 | 100% |  |  |  | 2023-12-22 | 2023-12-22 | 0d |  |  |  |  |  | SI Test | PP | DBT | 5.15 |  | Design, Build & Test (PIT) | Complete | COMPLETE | T3-DB-0176 | SITAG | T3 |  |  |
| 442 | 1.3.6.4.6 | **All UMSO DBT CIT (Entering at Interval 6)** |  | 81d | 2023-09-29 | 2024-01-19 A |  | 100% |  | 2023-10-13 |  | 2023-09-29 | 2024-01-19 | 320d | 2022-10-31 | 2024-05-13 |  |  | -0 | N/A | N/A | DBT | 5.0 | N/A | Design, Build & Test (PIT) |  |  |  |  |  |  |  |
| 443 | 1.3.6.4.6.1 | **Test Approach & Plan** |  | 20d | 2023-10-13 A | 2023-11-09 A |  | 100% |  |  |  | 2023-10-13 | 2023-11-09 | 40d | 2022-10-31 | 2023-09-29 |  |  | -0 | N/A | N/A | DBT | 5.0 | N/A | Design, Build & Test (PIT) |  |  |  |  |  |  |  |
| 444 | 1.3.6.4.6.1.1 | All UMSO Test Approach & Plans (PIT) submitted to Programme for assurance | milestone | 0d | 2023-10-13 A | 2023-10-13 A |  | 100% |  |  |  | 2023-10-13 | 2023-10-13 | 0d | 2023-09-15 | 2023-09-15 |  | start no earlier than 2023-10-13 |  | PP | SI Test | DBT | 5.11 |  | Design, Build & Test (PIT) | Complete | COMPLETE | T3-DB-0052 | SITAG | T3 |  |  |
| 445 | 1.3.6.4.6.1.2 | All UMSO Test Approach & Plans MHHS Review Completed | milestone | 0d | 2023-11-09 A | 2023-11-09 A | 444FS+20d | 100% |  |  |  | 2023-11-09 | 2023-11-09 | 0d | 2023-09-18 | 2023-09-29 |  |  |  | SI Test | PP | DBT | 5.10 |  | Design, Build & Test (PIT) | Complete | COMPLETE | T3-DB-0177 | SITAG | T3 |  |  |
| 446 | 1.3.6.4.6.2 | **Test Readiness Report** |  | 11d | 2023-09-29 | 2023-10-13 |  | 100% |  | 2023-10-27 | 2023-11-10 | 2023-09-29 | 2023-10-13 | 11d | 2023-09-29 | 2023-12-08 |  |  | -0 | N/A | N/A | DBT | 5.0 | N/A | Design, Build & Test (PIT) |  |  |  |  |  |  |  |
| 447 | 1.3.6.4.6.2.1 | Test readiness reporting |  | 11d | 2023-10-27 A | 2023-11-10 A | 444FS+10d | 100% |  |  |  | 2023-10-27 | 2023-11-10 | 11d | 2023-09-29 | 2023-12-08 |  |  |  | PP | 109 | DBT | 5.0 |  | Design, Build & Test (PIT) | Complete | COMPLETE |  |  |  |  |  |
| 448 | 1.3.6.4.6.3 | **Requirements to test Traceability Matrix (RTTM)** |  | 20d | 2023-10-05 | 2023-11-01 |  | 100% |  | 2023-11-02 | 2023-11-30 | 2023-10-05 | 2023-11-01 | 20d | 2022-10-31 | 2023-10-20 |  |  | -0 | N/A | N/A | DBT | 5.0 | N/A | Design, Build & Test (PIT) |  |  |  |  |  |  |  |
| 449 | 1.3.6.4.6.3.1 | All UMSO RTTMs submitted to Programme for assurance | milestone | 0d | 2023-11-02 A | 2023-11-02 A | 444FS+15d | 100% |  |  |  | 2023-11-02 | 2023-11-02 | 0d | 2023-10-06 | 2023-10-06 |  |  |  | PP | SI Test | DBT | 5.12 |  | Design, Build & Test (PIT) | Complete | COMPLETE | T3-DB-0060 | SITAG | T3 | MHHS-ART009 |  |
| 450 | 1.3.6.4.6.3.2 | All UMSO RTTMs MHHS Review Completed | milestone | 0d | 2023-11-30 A | 2023-11-30 A | 449FS+20d | 100% |  |  |  | 2023-11-30 | 2023-11-30 | 0d | 2023-10-09 | 2023-10-20 |  |  |  | SI Test | PP | DBT | 5.12 |  | Design, Build & Test (PIT) | Complete | COMPLETE | T3-DB-0178 | SITAG | T3 |  |  |
| 451 | 1.3.6.4.6.4 | **Test Scenarios** |  | 20d | 2023-10-05 | 2023-11-01 |  | 100% |  | 2023-11-02 | 2023-11-30 | 2023-10-05 | 2023-11-01 | 20d | 2022-10-31 | 2023-10-20 |  |  | -0 | N/A | N/A | DBT | 5.0 | N/A | Design, Build & Test (PIT) |  |  |  |  |  |  |  |
| 452 | 1.3.6.4.6.4.1 | All UMSO test scenarios' submitted to Programme for assurance | milestone | 0d | 2023-11-02 A | 2023-11-02 A | 444FS+15d | 100% |  |  |  | 2023-11-02 | 2023-11-02 | 0d | 2023-10-06 | 2023-10-06 |  |  |  | PP | SI Test | DBT | 5.12 |  | Design, Build & Test (PIT) | Complete | COMPLETE | T3-DB-0025 | SITAG | T3 |  |  |
| 453 | 1.3.6.4.6.4.2 | All UMSO Test scenarios' MHHS Review Completed | milestone | 0d | 2023-11-30 A | 2023-11-30 A | 452FS+20d | 100% |  |  |  | 2023-11-30 | 2023-11-30 | 0d | 2023-10-09 | 2023-10-20 |  |  |  | SI Test | PP | DBT | 5.10 |  | Design, Build & Test (PIT) | Complete | COMPLETE | T3-DB-0179 | SITAG | T3 |  |  |
| 454 | 1.3.6.4.6.5 | **PIT execution** |  | 51d | 2023-11-10 A | 2024-01-19 A |  | 100% |  |  |  | 2023-11-10 | 2024-01-19 | 320d | 2022-10-31 | 2023-12-08 |  |  | -0 | N/A | N/A | DBT | 5.0 | N/A | Design, Build & Test (PIT) |  |  |  |  |  |  |  |
| 455 | 1.3.6.4.6.5.1 | PIT Test Execution Progress Report |  | 40d | 2023-11-13 A | 2024-01-05 A | 452FS+5d, 447 | 100% |  |  |  | 2023-11-13 | 2024-01-05 | 40d | 2022-10-31 | 2023-12-01 |  |  |  | PP | SI Test | DBT | 5.0 |  | Design, Build & Test (PIT) | Complete | COMPLETE |  |  |  |  |  |
| 456 | 1.3.6.4.6.5.2 | PIT Execution |  | 40d | 2023-11-10 A | 2024-01-04 A | 452FS+5d | 100% |  |  |  | 2023-11-10 | 2024-01-04 | 290d | 2022-10-31 | 2023-12-08 |  |  |  | PP | SI Test | DBT | 5.0 |  | Design, Build & Test (PIT) | Complete | COMPLETE |  |  |  |  |  |
| 457 | 1.3.6.4.6.5.3 | All UMSO PIT (CIT interval 6) Completion Reports submitted to Programme for assurance | milestone | 0d | 2024-01-05 A | 2024-01-05 A | 456, 455 | 100% |  |  |  | 2024-01-05 | 2024-01-05 | 0d | 2024-01-05 | 2024-01-05 |  |  |  | PP | SI Test | DBT | 5.10 |  | Design, Build & Test (PIT) | Complete | COMPLETE | T3-DB-0180 | SITAG | T3 |  |  |
| 458 | 1.3.6.4.6.5.4 | All UMSO PIT (CIT interval 6) Completion Reports MHHS Review Completed | milestone | 0d | 2024-01-19 A | 2024-01-19 A | 445, 450, 453, 457FS+10d | 100% |  |  |  | 2024-01-19 | 2024-01-19 | 0d |  |  |  |  |  | SI Test | PP | DBT | 5.10 |  | Design, Build & Test (PIT) | Complete | COMPLETE | T3-DB-0181 | SITAG | T3 |  |  |
| 459 | 1.3.7 | **DBT Monitoring and Assurance** |  | 842d | 2022-10-31 A | 2026-01-20 |  | 69% | 262.62d |  |  | 2022-10-31 | 2026-01-20 | 842d | 2022-10-31 | 2026-01-19 | 502d |  |  | N/A | N/A | DBT | 5.0 | N/A | Design, Build & Test (PIT) |  |  |  |  |  |  |  |
| 460 | 1.3.7.1 | **Planning and DBT Progress Monitoring of PPs** |  | 696d | 2022-10-31 A | 2025-06-30 |  | 67% | 233d |  |  | 2022-10-31 | 2025-06-30 | 696d | 2022-10-31 | 2025-06-30 | 648d |  |  | N/A | N/A | DBT | 5.0 | N/A | Design, Build & Test (PIT) |  |  |  |  |  |  | M9 |
| 461 | 1.3.7.1.1 | Monitor Non-SIT PPs Planning and DBT1 progress (to inform confirmation of Qualification Testing Tranche participants milestones) |  | 696d | 2022-10-31 A | 2025-06-30 | 173SS | 67% | 233d |  |  | 2022-10-31 | 2025-06-30 | 696d | 2022-10-31 | 2025-06-30 | 648d |  |  | Code Bodies | SI Test,PPC | DBT | 5.0 | Roger Robar | Design, Build & Test (PIT) | Green | GREEN |  |  |  |  |  |

Notes:
- 461: 15/9 - hold in plan until qualification sections updated

| ID | WBS | Task | Type | Duration | Start | Finish | Predecessors | Complete | Remaining | Baseline start | Baseline finish | Baseline duration | Baseline 1 start | Baseline 1 finish | Total slack | Constraint | Responsible | Involved | Text9 | Task Status | Update Version | MHHS Resource Name | MHHS Programme Phase | Sched Status | RAG | Milestone ID | Text29 | Tier | Artefact ID |
| --- | --- | --- | --- | --- | --- | --- | --- | --- | --- | --- | --- | --- | --- | --- | --- | --- | --- | --- | --- | --- | --- | --- | --- | --- | --- | --- | --- | --- | --- |
| 462 | 1.3.7.2 | **DBT Progress Monitoring of Consequential Change** |  | 774d | 2023-02-02 A | 2026-01-20 |  | 51% | 379d | 2023-02-02 | 2026-01-20 | 774d | 2023-02-01 | 2026-01-19 | 502d |  | N/A | N/A | DBT | M9 | 5.0 | N/A | Design, Build & Test (PIT) |  |  |  |  |  |  |
| 463 | 1.3.7.2.1 | Monitor & report data cleanse progress |  | 774d | 2023-02-02 A | 2026-01-20 |  | 51% | 379d | 2023-02-02 | 2026-01-20 | 774d | 2023-02-01 | 2026-01-19 | 502d |  | SI Test | PPC | DBT |  | 5.0 | Matthew Breen | Design, Build & Test (PIT) | Green | GREEN |  |  |  |  |
| 464 | 1.3.7.3 | **Design Assurance** |  | 713d | 2022-11-14 A | 2025-08-06 |  | 80% | 142.32d | 2022-11-14 | 2025-08-06 | 713d | 2022-11-14 | 2025-08-06 | 621d |  | N/A | N/A | DBT | M9 | 5.0 | N/A | Design, Build & Test (PIT) |  |  |  |  |  |  |
| 465 | 1.3.7.3.1 | **Design Assurance Readiness Assessment Preparation** |  | 39d | 2023-02-28 A | 2023-04-21 A |  | 100% |  | 2023-02-28 | 2023-04-21 | 39d | 2023-02-28 | 2023-04-21 |  |  | N/A | N/A | DBT |  | 5.0 | N/A | Design, Build & Test (PIT) |  |  |  |  |  |  |
| 466 | 1.3.7.3.1.1 | Set up FTIG |  | 15d | 2023-04-03 A | 2023-04-21 A |  | 100% |  | 2023-04-03 | 2023-04-21 | 15d | 2023-04-03 | 2023-04-21 |  | must start on 2023-04-03 | SI Design |  | DBT |  | 5.0 | Paul Pettitt | Design, Build & Test (PIT) | Complete | COMPLETE |  |  |  |  |
| 467 | 1.3.7.3.1.2 | Produce Draft Questions |  | 10d | 2023-02-28 A | 2023-03-13 A |  | 100% |  | 2023-02-28 | 2023-03-13 | 10d | 2023-02-28 | 2023-03-13 |  | must start on 2023-02-28 | SI Design |  | DBT |  | 5.0 | Paul Pettitt | Design, Build & Test (PIT) | Complete | COMPLETE |  |  |  |  |
| 468 | 1.3.7.3.1.3 | Pilot with SRO |  | 1d | 2023-03-14 A | 2023-03-14 A | 467 | 100% |  | 2023-03-14 | 2023-03-14 | 1d | 2023-03-14 | 2023-03-14 |  |  | SI Design |  | DBT |  | 5.0 | Paul Pettitt | Design, Build & Test (PIT) | Complete | COMPLETE |  |  |  |  |
| 469 | 1.3.7.3.1.4 | Finalise questions |  | 10d | 2023-03-15 A | 2023-03-28 A | 468 | 100% |  | 2023-03-15 | 2023-03-28 | 10d | 2023-03-15 | 2023-03-28 |  |  | SI Design |  | DBT |  | 5.0 | Paul Pettitt | Design, Build & Test (PIT) | Complete | COMPLETE |  |  |  |  |
| 470 | 1.3.7.3.1.5 | Prepare on-line RA tooling |  | 10d | 2023-03-29 A | 2023-04-11 A | 469 | 100% |  | 2023-03-29 | 2023-04-11 | 10d | 2023-03-29 | 2023-04-11 |  |  | SI Design |  | DBT |  | 5.0 | Paul Pettitt | Design, Build & Test (PIT) | Complete | COMPLETE |  |  |  |  |
| 471 | 1.3.7.3.1.6 | Prepare webinar content |  | 5d | 2023-03-20 A | 2023-03-24 A | 467FS+4d | 100% |  | 2023-03-20 | 2023-03-24 | 5d | 2023-03-20 | 2023-03-24 |  |  | SI Design |  | DBT |  | 5.0 | Paul Pettitt | Design, Build & Test (PIT) | Complete | COMPLETE |  |  |  |  |
| 472 | 1.3.7.3.1.7 | Conduct webinar |  | 1d | 2023-03-30 A | 2023-03-30 A | 471FS+3d | 100% |  | 2023-03-30 | 2023-03-30 | 1d | 2023-03-30 | 2023-03-30 |  |  | SI Design | PP | DBT |  | 5.0 | Paul Pettitt | Design, Build & Test (PIT) | Complete | COMPLETE |  |  |  |  |
| 473 | 1.3.7.3.2 | **Participant Design Assurance Approach** |  | 43d | 2022-11-14 A | 2023-01-11 A |  | 100% |  | 2022-11-14 | 2023-01-11 | 43d | 2022-11-14 | 2023-01-11 |  |  | N/A | N/A | DBT |  | 5.0 | N/A | Design, Build & Test (PIT) |  |  |  |  |  |  |
| 474 | 1.3.7.3.2.1 | Develop document |  | 20d | 2022-11-14 A | 2022-12-09 A | 47FS+10d | 100% |  | 2022-11-14 | 2022-12-09 | 20d | 2022-11-14 | 2022-12-09 |  | start no earlier than 2022-11-14 | SI Design | PP | DBT |  | 5.0 | Paul Pettitt | Design, Build & Test (PIT) | Complete | COMPLETE |  |  |  |  |
| 475 | 1.3.7.3.2.2 | Review document |  | 18d | 2022-12-12 A | 2023-01-04 A | 474 | 100% |  | 2022-12-12 | 2023-01-04 | 18d | 2022-12-12 | 2023-01-04 |  |  | PP | SI Design,IPA | DBT |  | 5.0 | Paul Pettitt | Design, Build & Test (PIT) | Complete | COMPLETE |  |  |  |  |
| 476 | 1.3.7.3.2.3 | Participant Design Assurance Approach approved | milestone | 0d | 2023-01-11 A | 2023-01-11 A | 475FF+5d | 100% |  | 2023-01-11 | 2023-01-11 | 0d | 2023-01-11 | 2023-01-11 |  |  | SI Design | PP | DBT |  | 5.0 | Paul Pettitt | Design, Build & Test (PIT) | Complete | COMPLETE | T3-DB-0012 | DAG | T3 |  |
| 477 | 1.3.7.3.3 | **Phase 1 - SIT Volunteers (Core Providers)** |  | 145d | 2023-04-10 A | 2023-10-27 A |  | 100% |  | 2023-04-10 | 2023-10-27 | 145d | 2023-04-10 | 2023-10-27 |  |  | N/A | N/A | DBT |  | 5.0 | N/A | Design, Build & Test (PIT) |  |  |  |  |  |  |
| 478 | 1.3.7.3.3.1 | Send on-line questionnaire to core capability providers and current SIT volunteers (from Round 3 consultation) |  | 1d | 2023-04-10 A | 2023-04-10 A |  | 100% |  | 2023-04-10 | 2023-04-10 | 1d | 2023-04-10 | 2023-04-10 |  | must start on 2023-04-10 | SI Design | PP | DBT |  | 5.0 | Paul Pettitt | Design, Build & Test (PIT) | Complete | COMPLETE |  |  |  |  |
| 479 | 1.3.7.3.3.2 | Participants Provide Responses to questionnaires |  | 15d | 2023-04-11 A | 2023-05-01 A | 478 | 100% |  | 2023-04-11 | 2023-05-01 | 15d | 2023-04-11 | 2023-05-01 |  |  | PP |  | DBT |  | 5.0 | Paul Pettitt | Design, Build & Test (PIT) | Complete | COMPLETE |  |  |  |  |
| 480 | 1.3.7.3.3.3 | Assess on-line responses and provided evidence |  | 5d | 2023-05-02 A | 2023-05-08 A | 479 | 100% |  | 2023-05-02 | 2023-05-08 | 5d | 2023-05-02 | 2023-05-08 |  |  | SI Design |  | DBT |  | 5.0 | Paul Pettitt | Design, Build & Test (PIT) | Complete | COMPLETE |  |  |  |  |
| 481 | 1.3.7.3.3.4 | Bi-lateral meeting with each responder, to walk and navigate through provided materials |  | 31d | 2023-05-09 A | 2023-06-20 A | 480 | 100% |  | 2023-05-09 | 2023-06-20 | 31d | 2023-05-09 | 2023-06-20 |  |  | SI Design | PP | DBT |  | 5.0 | Paul Pettitt | Design, Build & Test (PIT) | Complete | COMPLETE |  |  |  |  |
| 482 | 1.3.7.3.3.5 | Plan for, create and execute deep dive assurance interviews based on agreed priorities (participants, design areas) |  | 62d | 2023-06-07 A | 2023-08-31 A | 481FS-10d | 100% |  | 2023-06-07 | 2023-08-31 | 62d | 2023-06-07 | 2023-08-01 |  |  | SI Design |  | DBT |  | 5.2 | Paul Pettitt | Design, Build & Test (PIT) | Complete | COMPLETE |  |  |  |  |
| 483 | 1.3.7.3.3.6 | SI endorsement of participants’ design – assurance reports |  | 43d | 2023-08-02 A | 2023-09-29 A | 482FS-22d | 100% |  | 2023-08-02 | 2023-09-29 | 43d | 2023-08-02 | 2023-08-15 |  |  | SI Design |  | DBT |  | 5.2 | Paul Pettitt | Design, Build & Test (PIT) | Complete | COMPLETE |  |  |  |  |
| 484 | 1.3.7.3.3.7 | Post-assurance review of recommendations take-up by assured participants |  | 44d | 2023-08-29 A | 2023-10-27 A | 483SS+19d | 100% |  | 2023-08-29 | 2023-10-27 | 20d | 2023-08-16 | 2023-10-27 |  |  | SI Design |  | DBT |  | 5.2 | Paul Pettitt | Design, Build & Test (PIT) | Complete | COMPLETE |  |  |  |  |
| 485 | 1.3.7.3.3.8 | Phase 1 - SIT Volunteers (Core Providers) complete | milestone | 0d | 2023-10-27 A | 2023-10-27 A | 484 | 100% |  | 2023-10-27 | 2023-10-27 | 0d | 2023-10-27 | 2023-10-27 |  |  | SI Design |  | DBT |  | 5.11 | Paul Pettitt | Design, Build & Test (PIT) | Complete | COMPLETE | T2-DB-0100 | DAG | T2 | MHHS-ART002 |

Notes:
- 463: 15/9 - query with John Wiggins where this sits

| ID | WBS | Task | Type | Duration | Start | Finish | Predecessors | Complete | Remaining | Baseline start | Baseline finish | Baseline duration | Baseline 1 start | Baseline 1 finish | Total slack | Constraint | Baseline cost | Responsible | Involved | Text9 | Update Version | MHHS Resource Name | MHHS Programme Phase | Sched Status | RAG | Artefact ID | Milestone ID | Text29 | Tier | Task Status | Future RAG |
| --- | --- | --- | --- | --- | --- | --- | --- | --- | --- | --- | --- | --- | --- | --- | --- | --- | --- | --- | --- | --- | --- | --- | --- | --- | --- | --- | --- | --- | --- | --- | --- |
| 486 | 1.3.7.3.4 | **Phase 2 - SIT all other participants** |  | 143d | 2023-05-08 A | 2023-11-22 A |  | 100% |  | 2023-05-08 | 2023-11-22 | 143d | 2023-05-08 | 2023-11-22 |  |  |  | N/A | N/A | DBT | 5.0 | N/A | Design, Build & Test (PIT) |  |  |  |  |  |  |  |  |
| 487 | 1.3.7.3.4.1 | Send on-line questionnaire to core capability providers and current SIT volunteers (from Round 3 consultation) |  | 1d | 2023-05-08 A | 2023-05-08 A |  | 100% |  | 2023-05-08 | 2023-05-08 | 1d | 2023-05-08 | 2023-05-08 |  | must start on 2023-05-08 |  | SI Design | PP | DBT | 5.0 | Paul Pettitt | Design, Build & Test (PIT) | Complete | COMPLETE |  |  |  |  |  |  |
| 488 | 1.3.7.3.4.2 | Participants Provide Responses to questionnaires |  | 15d | 2023-05-09 A | 2023-05-29 A | 487 | 100% |  | 2023-05-09 | 2023-05-29 | 15d | 2023-05-09 | 2023-05-29 |  |  |  | PP |  | DBT | 5.0 | Paul Pettitt | Design, Build & Test (PIT) | Complete | COMPLETE |  |  |  |  |  |  |
| 489 | 1.3.7.3.4.3 | Assess on-line responses and provided evidence |  | 5d | 2023-05-30 A | 2023-06-05 A | 488 | 100% |  | 2023-05-30 | 2023-06-05 | 5d | 2023-05-30 | 2023-06-05 |  |  |  | SI Design |  | DBT | 5.0 | Paul Pettitt | Design, Build & Test (PIT) | Complete | COMPLETE |  |  |  |  |  |  |
| 490 | 1.3.7.3.4.4 | Bi-lateral meeting with each responder, to walk and navigate through provided materials |  | 84d | 2023-06-06 A | 2023-09-29 A | 489 | 100% |  | 2023-06-06 | 2023-09-29 | 84d | 2023-06-06 | 2023-07-18 |  |  |  | SI Design | PP | DBT | 5.2 | Paul Pettitt | Design, Build & Test (PIT) | Complete | COMPLETE |  |  |  |  |  |  |
| 491 | 1.3.7.3.4.5 | Plan for, create and execute deep dive assurance interviews based on agreed priorities (participants, design areas) |  | 69d | 2023-06-27 A | 2023-09-29 A | 490SS+15d | 100% |  | 2023-06-27 | 2023-09-29 | 69d | 2023-07-05 | 2023-08-29 |  |  |  | SI Design |  | DBT | 5.2 | Paul Pettitt | Design, Build & Test (PIT) | Complete | COMPLETE |  |  |  |  |  |  |
| 492 | 1.3.7.3.4.6 | SI endorsement of participants’ design – assurance reports |  | 54d | 2023-07-18 A | 2023-09-29 A | 491SS+15d | 100% |  | 2023-07-18 | 2023-09-29 | 54d | 2023-08-30 | 2023-09-12 |  |  |  | SI Design |  | DBT | 5.2 | Paul Pettitt | Design, Build & Test (PIT) | Complete | COMPLETE |  |  |  |  |  |  |
| 493 | 1.3.7.3.4.7 | Post-assurance review of recommendations take-up by assured participants |  | 73d | 2023-08-14 A | 2023-11-22 A | 492SS+19d | 100% |  | 2023-08-14 | 2023-11-22 | 38d | 2023-09-13 | 2023-11-22 |  |  |  | SI Design |  | DBT | 5.2 | Paul Pettitt | Design, Build & Test (PIT) | Complete | COMPLETE |  |  |  |  |  |  |
| 494 | 1.3.7.3.4.8 | SIT PPs design assurance (excl Migration/Reverse Migration) complete | milestone | 0d | 2023-11-22 A | 2023-11-22 A | 493 | 100% |  | 2023-11-22 | 2023-11-22 | 0d | 2023-11-22 | 2023-11-22 |  |  |  | SI Design |  | DBT | 5.11 | Paul Pettitt | Design, Build & Test (PIT) | Complete | COMPLETE | MHHS-ART002 | T2-DB-0200 | DAG | T2 |  |  |
| 495 | 1.3.7.3.5 | **Non-SIT PPs design assurance** |  | 445d | 2023-11-23 A | 2025-08-06 |  | 53% | 207d | 2023-11-23 | 2025-08-06 | 445d | 2023-11-23 | 2025-08-06 | 621d |  |  | N/A | N/A | DBT | 5.0 | N/A | Design, Build & Test (PIT) |  |  |  |  |  |  |  |  |
| 496 | 1.3.7.3.5.1 | Non-SIT PPs design assurance (risk-based sample) |  | 445d | 2023-11-23 A | 2025-08-06 | 494 | 53% | 207d | 2023-11-23 | 2025-08-06 | 445d | 2023-11-23 | 2025-08-06 | 621d |  |  | SI Design | PPC | DBT | 5.0 | Paul Pettitt | Design, Build & Test (PIT) | Green | GREEN |  |  |  |  |  |  |
| 497 | 1.3.7.4 | **Test Assurance** |  | 629d | 2023-02-01 A | 2025-06-30 |  | 71% | 180d | 2023-02-01 | 2025-06-30 | 696d | 2022-10-31 | 2025-06-30 | 648d |  |  | N/A | N/A | DBT | 5.0 | N/A | Design, Build & Test (PIT) |  |  |  |  |  |  | M9 |  |
| 498 | 1.3.7.4.1 | Non-SIT PPs test assurance |  | 629d | 2023-02-01 A | 2025-06-30 |  | 71% | 180d | 2023-02-01 | 2025-06-30 | 629d | 2023-02-01 | 2025-06-30 | 648d |  |  | Code Bodies | PP,PPC,SI Test | DBT | 5.0 | Roger Robar | Design, Build & Test (PIT) | Green | GREEN |  |  |  |  |  |  |
| 499 | 1.3.7.5 | **Pre-Qualification Guidance (PIT Guidance)** |  | 67d | 2022-10-31 A | 2023-01-31 A |  | 100% |  | 2022-10-31 | 2023-01-31 | 67d | 2022-10-31 | 2023-01-31 |  |  |  | N/A | N/A | DBT | 5.0 | N/A | Design, Build & Test (PIT) |  |  |  |  |  |  |  |  |
| 500 | 1.3.7.5.1 | Develop document (incl. collaboration with code bodies, as required) |  | 56d | 2022-10-31 A | 2023-01-16 A |  | 100% |  | 2022-10-31 | 2023-01-16 | 56d | 2022-10-31 | 2023-01-16 |  |  |  | SI Test | Code Bodies | DBT | 5.0 |  | Design, Build & Test (PIT) | Complete | COMPLETE |  |  |  |  |  |  |
| 501 | 1.3.7.5.2 | Review, update and agree Pre-Qualification Guidance internally |  | 11d | 2023-01-17 A | 2023-01-31 A | 500 | 100% |  | 2023-01-17 | 2023-01-31 | 11d | 2023-01-17 | 2023-01-31 |  |  |  | SRO Function | IPA,SI Test | DBT | 5.0 |  | Design, Build & Test (PIT) | Complete | COMPLETE |  |  |  |  |  |  |
| 502 | 1.3.7.6 | **External Programme Dependency Management** |  | 0d | 2022-11-03 A | 2022-11-03 A |  | 100% |  | 2022-11-03 | 2022-11-03 | 0d | 2022-11-03 | 2022-11-03 |  |  |  | N/A | N/A | DBT | 5.0 | N/A | Design, Build & Test (PIT) |  |  |  |  |  |  |  |  |
| 503 | 1.3.7.6.1 | **SLC47** |  | 0d | 2022-11-03 A | 2022-11-03 A |  | 100% |  | 2022-11-03 | 2022-11-03 | 0d | 2022-11-03 | 2022-11-03 |  |  |  | N/A | N/A | DBT | 5.0 | N/A | Design, Build & Test (PIT) |  |  |  |  |  |  |  |  |
| 504 | 1.3.7.6.1.1 | SLC47 implementation date | milestone | 0d | 2022-11-03 A | 2022-11-03 A |  | 100% |  | 2022-11-03 | 2022-11-03 | 0d | 2022-11-03 | 2022-11-03 |  | start no earlier than 2022-11-03 |  | Ofgem |  | DBT | 5.0 |  | Design, Build & Test (PIT) | Complete | COMPLETE |  |  |  |  |  |  |
| 505 | 1.4 | **SYSTEMS INTEGRATION TESTING (SIT)** |  | 910d? | 2022-10-31 A | 2026-04-24 |  | 65% | 316.9d? | 2022-10-31 | 2026-04-24 | 841d | 2022-10-31 | 2026-01-19 |  |  | -0 | N/A | N/A | SIT |  | N/A | Systems Integration Testing (SIT) |  |  |  |  | SITAG |  |  | 1 Aug 2023 - 30 Sep 2024 |
| 506 | 1.4.1 | **SIT Preparation** |  | 665d? | 2022-10-31 A | 2025-05-16 |  | 83% | 114.6d? | 2022-10-31 | 2025-05-16 | 611d | 2022-10-31 | 2025-03-10 | 679d |  | -0 | N/A | N/A | SIT | 5.0 | N/A | Systems Integration Testing (SIT) |  |  |  |  | SITAG |  |  |  |
| 507 | 1.4.1.1 | **Test Artefact Development** |  | 472d | 2022-10-31 A | 2024-08-21 |  | 99% | 2.69d | 2022-10-31 | 2024-08-21 | 472d | 2022-10-31 | 2023-09-01 | 872d |  | -0 | N/A | N/A | SIT | 5.0 | N/A | Systems Integration Testing (SIT) |  |  |  |  |  |  | M9 |  |
| 508 | 1.4.1.1.1 | **Environment Approach & Plan** |  | 460d | 2022-11-16 A | 2024-08-21 A |  | 100% |  | 2022-11-16 | 2024-08-21 | 460d | 2022-11-16 | 2023-06-30 |  |  | -0 | N/A | N/A | SIT | 5.0 | N/A | Systems Integration Testing (SIT) |  |  |  |  |  |  |  |  |
| 509 | 1.4.1.1.1.1 | Environment Approach & Plan approved | milestone | 0d | 2022-11-16 A | 2022-11-16 A |  | 100% |  | 2022-11-16 | 2022-11-16 | 0d | 2022-11-16 | 2022-11-16 |  | start no earlier than 2022-11-16 |  | SI Test | PP | SIT | 5.0 | Simon Berry | Systems Integration Testing (SIT) | Complete | COMPLETE | MHHS-ART139 | T3-TE-0010 | SITAG | T3 |  |  |
| 510 | 1.4.1.1.1.2 | Environment Approach & Plan - Work Off |  | 157d | 2022-11-17 A | 2023-06-23 A | 509FS+1d | 100% |  | 2022-11-17 | 2023-06-23 | 157d | 2022-11-17 | 2023-06-23 |  |  |  | SI Test | PP | SIT | 5.0 | Simon Berry | Systems Integration Testing (SIT) | Complete | COMPLETE |  |  |  |  |  |  |
| 511 | 1.4.1.1.1.3 | Environment Approach & Plan - Work Off Approved | milestone | 0d | 2023-08-16 A | 2023-08-16 A | 510FS+5d | 100% |  | 2023-08-16 | 2023-08-16 | 0d | 2023-06-30 | 2023-06-30 |  | start no earlier than 2023-08-16 |  | SI Test | PP | SIT | 5.0 | Simon Berry | Systems Integration Testing (SIT) | Complete | COMPLETE | MHHS-ART139 | T3-TE-0068 | SITAG | T3 |  |  |
| 512 | 1.4.1.1.1.4 | Environment Approach and Plan - SIT Functional | milestone | 0d | 2023-11-20 A | 2023-11-20 A |  | 100% |  | 2023-11-20 | 2023-11-20 | 0d |  |  |  | start no earlier than 2023-11-20 |  | SI Test | PP | SIT | 5.12 | Simon Berry | Systems Integration Testing (SIT) | Complete | COMPLETE | MHHS-DEL 618 | T3-TE-0090 | SITAG | T3 |  |  |
| 513 | 1.4.1.1.1.5 | Define Approach to Simulator for Non-SIT LDSO | milestone | 0d | 2023-11-15 A | 2023-11-15 A |  | 100% |  | 2023-11-15 | 2023-11-15 | 0d |  |  |  | start no earlier than 2023-11-15 |  | SI Test | PP | SIT | 5.12 | Simon Berry |  | Complete | COMPLETE |  |  |  |  |  |  |
| 514 | 1.4.1.1.1.6 | Environment Approach and Plan - Non SIT LDSO Testing | milestone | 0d | 2024-04-17 A | 2024-04-17 A |  | 100% |  | 2024-04-17 | 2024-04-17 | 0d |  |  |  | start no earlier than 2024-04-17 |  | SI Test | PP | SIT | 5.22 | Simon Berry | Systems Integration Testing (SIT) | Complete | COMPLETE | MHHS-DEL 619 | T3-TE-0091 | SITAG/QAG | T3 |  |  |
| 515 | 1.4.1.1.1.7 | Environment Approach and Plan - S and A Testing | milestone | 0d | 2024-07-17 A | 2024-07-17 A |  | 100% |  | 2024-07-17 | 2024-07-17 | 0d |  |  |  | start no earlier than 2024-07-17 |  | SI Test | PP | SIT | 5.27 | Simon Berry | Systems Integration Testing (SIT) | Complete | COMPLETE | MHHS-DEL 619 | T3-TE-0120 | SITAG/QAG | T3 |  |  |
| 516 | 1.4.1.1.1.8 | Environment Approach and Plan - SIT Non Functional | milestone | 0d | 2024-06-19 A | 2024-06-19 A |  | 100% |  | 2024-06-19 | 2024-06-19 | 0d |  |  |  | start no earlier than 2024-06-19 |  | SI Test | PP | SIT | 5.27 | Simon Berry | Systems Integration Testing (SIT) | Complete | COMPLETE | MHHS-DEL 620 | T3-TE-0092 | SITAG | T3 |  |  |
| 517 | 1.4.1.1.1.9 | Environment Approach and Plan - Sandbox | milestone | 0d | 2024-08-21 A | 2024-08-21 A |  | 100% |  | 2024-08-21 | 2024-08-21 | 0d |  |  |  | start no earlier than 2024-08-21 |  | SI Test | PP | SIT | 5.27 | Simon Berry | Systems Integration Testing (SIT) | Complete | COMPLETE | MHHS-DEL 621 | T3-TE-0093 | SITAG/QAG | T3 |  |  |

Notes:
- 498: 15/9 - keep in plan until qualification reviewed
- 506: Action: 11/3: Ask Simon B for the link (line 1312) dip onboarding to non sit ldso
- 508: Action: 16/8 - add to milestone register. Build out detail further
- 509: Action: 25/7 - Simon to provide update
- 510: Action: 25/7 - Simon to provide update
- 511: Action: 25/7 - Simon to provide update
- 512: Action: 16/8 - add to milestone register. Build out detail further
- 514: Action: 16/8 - add to milestone register. Build out detail further
- 515: Action: 16/8 - add to milestone register. Build out detail further
- 516: Action: 16/8 - add to milestone register. Build out detail further
- 517: Action: 16/8 - add to milestone register. Build out detail further

| ID | WBS | Task | Type | Duration | Start | Finish | Predecessors | Complete | Remaining | Baseline start | Baseline finish | Baseline duration | Baseline 1 start | Baseline 1 finish | Total slack | Constraint | Baseline cost | Responsible | Involved | Text9 | Update Version | MHHS Resource Name | MHHS Programme Phase | Sched Status | RAG | Task Status | Milestone ID | Text29 | Tier |
| --- | --- | --- | --- | --- | --- | --- | --- | --- | --- | --- | --- | --- | --- | --- | --- | --- | --- | --- | --- | --- | --- | --- | --- | --- | --- | --- | --- | --- | --- |
| 518 | 1.4.1.1.2 | **Overarching Test Scope (for all stages)** |  | 65d | 2022-10-31 A | 2023-01-27 A |  | 100% |  | 2022-10-31 | 2023-01-27 | 175d | 2022-10-31 | 2023-06-30 |  |  |  | N/A | N/A | SIT | 5.0 | N/A | Systems Integration Testing (SIT) |  |  |  |  |  |  |
| 519 | 1.4.1.1.2.1 | **Overarching Test Scope (excl. Migration/Reverse Migration, NFT and Ops components)** |  | 65d | 2022-10-31 A | 2023-01-27 A |  | 100% |  | 2022-10-31 | 2023-01-27 | 65d | 2022-10-31 | 2023-01-27 |  |  |  | N/A | N/A | SIT | 5.0 | N/A | Systems Integration Testing (SIT) |  |  |  |  |  |  |
| 520 | 1.4.1.1.2.1.1 | Develop document (excl Migration/Reverse Migration, NFT and Ops components) |  | 55d | 2022-10-31 A | 2023-01-13 A | 47 | 100% |  | 2022-10-31 | 2023-01-13 | 55d | 2022-10-31 | 2023-01-13 |  |  |  | SI Test |  | SIT | 5.0 |  | Systems Integration Testing (SIT) | Complete | COMPLETE |  |  |  |  |
| 521 | 1.4.1.1.2.1.2 | Review, update & agree document (excl Migration/Reverse Migration, NFT and Ops components) |  | 10d | 2023-01-16 A | 2023-01-27 A | 520 | 100% |  | 2023-01-16 | 2023-01-27 | 10d | 2023-01-16 | 2023-01-27 |  |  |  | SI Test | IPA,Code Bodies,PP | SIT | 5.0 |  | Systems Integration Testing (SIT) | Complete | COMPLETE |  |  |  |  |
| 522 | 1.4.1.1.3 | **Configuration and Release Management Approach & Plan** |  | 164d | 2022-11-01 A | 2023-06-16 A |  | 100% |  | 2022-11-01 | 2023-06-16 | 164d | 2022-11-01 | 2023-04-28 |  |  |  | N/A | N/A | SIT | 5.0 | N/A | Systems Integration Testing (SIT) |  |  | M9 |  |  |  |
| 523 | 1.4.1.1.3.1 | Develop document |  | 69d | 2022-11-01 A | 2023-06-16 A |  | 100% |  | 2022-11-01 | 2023-06-16 | 69d | 2022-11-01 | 2023-01-31 |  | start no earlier than 2022-11-01 |  | SI Test |  | SIT | 5.0 | Simon Berry | Systems Integration Testing (SIT) | Complete | COMPLETE |  |  |  |  |
| 524 | 1.4.1.1.3.2 | Review, update and agree Configuration and Release Management Approach & Plan internally |  | 63d | 2023-02-01 A | 2023-04-28 A | 523 | 100% |  | 2023-02-01 | 2023-04-28 | 63d | 2023-02-01 | 2023-04-28 |  |  |  | SRO Function | IPA,SI Test | SIT | 5.0 | Simon Berry | Systems Integration Testing (SIT) | Complete | COMPLETE |  |  |  |  |
| 525 | 1.4.1.1.4 | **Test Data Overarching Approach & Plan** |  | 179d | 2022-11-14 A | 2023-07-20 A |  | 100% |  | 2022-11-14 | 2023-07-20 | 179d | 2022-11-14 | 2023-05-18 |  |  |  | N/A | N/A | SIT | 5.0 | N/A | Systems Integration Testing (SIT) |  |  | M9 |  |  |  |
| 526 | 1.4.1.1.4.1 | Develop document |  | 20d | 2022-11-14 A | 2022-12-09 A |  | 100% |  | 2022-11-14 | 2022-12-09 | 20d | 2022-11-14 | 2022-12-09 |  | start no earlier than 2022-11-14 |  | SI Test | PP | SIT | 5.0 | Cesar Lopes | Systems Integration Testing (SIT) | Complete | COMPLETE |  |  |  |  |
| 527 | 1.4.1.1.4.2 | Document review and update |  | 155d | 2022-12-12 A | 2023-07-14 A | 526 | 100% |  | 2022-12-12 | 2023-07-14 | 155d | 2022-12-12 | 2023-05-17 |  |  |  | PP | SI Test,IPA | SIT | 5.0 | Cesar Lopes | Systems Integration Testing (SIT) | Complete | COMPLETE |  |  |  |  |
| 528 | 1.4.1.1.4.3 | Test Data Overarching Approach & Plan approved by TMAG | milestone | 0d | 2023-07-19 A | 2023-07-19 A | 527FS+3d | 100% |  | 2023-07-19 | 2023-07-19 | 0d | 2023-05-17 | 2023-05-17 |  |  |  | SRO Test | PP,IPA,Code Bodies | SIT | 5.0 | Cesar Lopes | Systems Integration Testing (SIT) | Complete | COMPLETE |  | T3-TE-0072 | SITAG | T3 |
| 529 | 1.4.1.1.4.4 | Document publication final version |  | 1d | 2023-07-20 A | 2023-07-20 A | 528 | 100% |  | 2023-07-20 | 2023-07-20 | 1d | 2023-05-18 | 2023-05-18 |  |  |  | SI Test |  | SIT | 5.0 | Cesar Lopes | Systems Integration Testing (SIT) | Complete | COMPLETE |  |  |  |  |
| 530 | 1.4.1.1.5 | **Interface Code of Connection (dates subject to DIP Service Provider's plan)** |  | 48d | 2023-03-01 A | 2023-05-05 A |  | 100% |  | 2023-03-01 | 2023-05-05 | 48d | 2023-03-01 | 2023-05-05 |  |  |  | N/A | N/A | SIT | 5.0 | N/A | Systems Integration Testing (SIT) |  |  |  |  |  |  |
| 531 | 1.4.1.1.5.1 | Develop Interface Code of Connection with DIP Service Provider |  | 43d | 2023-03-01 A | 2023-04-28 A |  | 100% |  | 2023-03-01 | 2023-04-28 | 43d | 2023-03-01 | 2023-04-28 |  | must start on 2023-03-01 |  | DIP Provider | SI Test | SIT | 5.0 |  | Systems Integration Testing (SIT) | Complete | COMPLETE |  |  |  |  |
| 532 | 1.4.1.1.5.2 | Interface Code of Connection approved at SDWG | milestone | 0d | 2023-05-05 A | 2023-05-05 A | 531FS+5d | 100% |  | 2023-05-05 | 2023-05-05 | 0d | 2023-05-05 | 2023-05-05 |  |  |  | SI Test | PP | SIT | 5.0 |  | Systems Integration Testing (SIT) | Complete | COMPLETE |  |  |  |  |
| 533 | 1.4.1.1.6 | **Test Traceability** |  | 165d | 2023-06-01 A | 2024-01-17 |  | 98% | 2.71d | 2023-06-01 | 2024-01-17 | 165d | 2023-06-01 | 2023-09-01 | 1026d |  | -0 | N/A | N/A | SIT | 5.0 | N/A | Systems Integration Testing (SIT) |  |  |  |  |  |  |
| 534 | 1.4.1.1.6.1 | RTM containing Method Statement Implied Requirements into Azure DevOps |  | 22d | 2023-06-01 A | 2023-06-30 A |  | 100% |  | 2023-06-01 | 2023-06-30 | 22d | 2023-06-01 | 2023-06-30 |  | must start on 2023-06-01 |  | SI Test |  | SIT | 5.0 |  | Systems Integration Testing (SIT) | Complete | COMPLETE |  |  |  |  |
| 535 | 1.4.1.1.6.2 | RTM Containing Interface Catalogue Implied Requirements |  | 27d | 2023-06-01 A | 2023-07-07 A |  | 100% |  | 2023-06-01 | 2023-07-07 | 27d | 2023-06-01 | 2023-07-07 |  | must start on 2023-06-01 |  | SI Test |  | SIT | 5.0 |  | Systems Integration Testing (SIT) | Complete | COMPLETE |  |  |  |  |
| 536 | 1.4.1.1.6.3 | SIT CIT Full Traceability & Coverage complete |  | 118d | 2023-07-10 A | 2023-12-20 A | 535, 534 | 100% |  | 2023-07-10 | 2023-12-20 | 110d | 2023-07-10 | 2023-07-28 |  |  |  | SI Test |  | SIT | 5.0 |  | Systems Integration Testing (SIT) | Complete | COMPLETE |  |  |  |  |
| 537 | 1.4.1.1.6.4 | SIT Functional Full Traceability & Coverage complete |  | 138d | 2023-07-10 A | 2024-01-17 | 535, 534 | 96% | 5d | 2023-07-10 | 2024-01-17 | 138d | 2023-07-10 | 2023-09-01 | 1026d |  |  | SI Test |  | SIT | 5.0 | Roger Robar | Systems Integration Testing (SIT) | Overdue | RED |  |  |  |  |
| 538 | 1.4.1.2 | **Test Tool Development** |  | 256d? | 2022-10-31 A | 2023-10-23 A |  | 100% |  | 2022-10-31 | 2023-10-23 | 175d | 2022-10-31 | 2023-06-30 |  |  |  | N/A | N/A | SIT | 5.0 | N/A | Systems Integration Testing (SIT) |  |  |  |  |  |  |
| 539 | 1.4.1.2.1 | **Test Management Tool** |  | 256d | 2022-10-31 A | 2023-10-23 A |  | 100% |  | 2022-10-31 | 2023-10-23 | 175d | 2022-10-31 | 2023-06-30 |  |  |  | N/A | N/A | SIT | 5.0 | N/A | Systems Integration Testing (SIT) |  |  |  |  |  |  |
| 540 | 1.4.1.2.1.1 | **Test Management Tool Implementation** |  | 256d | 2022-10-31 A | 2023-10-23 A |  | 100% |  | 2022-10-31 | 2023-10-23 | 175d | 2022-10-31 | 2023-06-30 |  |  |  | N/A | N/A | SIT | 5.0 | N/A | Systems Integration Testing (SIT) |  |  |  |  |  |  |
| 541 | 1.4.1.2.1.1.1 | Requirements identification |  | 40d | 2022-10-31 A | 2022-12-23 A |  | 100% |  | 2022-10-31 | 2022-12-23 | 40d | 2022-10-31 | 2022-12-23 |  |  |  | SI DevOps | SI Test | SIT | 5.0 | Simon Berry | Systems Integration Testing (SIT) | Complete | COMPLETE |  |  |  |  |
| 542 | 1.4.1.2.1.1.2 | Development |  | 125d | 2023-01-02 A | 2023-06-23 A | 541FS+5d | 100% |  | 2023-01-02 | 2023-06-23 | 125d | 2023-01-02 | 2023-06-23 |  |  |  | SI DevOps | SI Test | SIT | 5.0 | Simon Berry | Systems Integration Testing (SIT) | Complete | COMPLETE |  |  |  |  |
| 543 | 1.4.1.2.1.1.3 | Testing |  | 125d | 2023-01-02 A | 2023-06-23 A | 542FF | 100% |  | 2023-01-02 | 2023-06-23 | 125d | 2023-01-02 | 2023-06-23 |  |  |  | SI DevOps | SI Test | SIT | 5.0 | Simon Berry | Systems Integration Testing (SIT) | Complete | COMPLETE |  |  |  |  |
| 544 | 1.4.1.2.1.1.4 | Accept tool | milestone | 0d | 2023-06-23 A | 2023-06-23 A | 543FF | 100% |  | 2023-06-23 | 2023-06-23 | 0d | 2023-06-23 | 2023-06-23 |  |  |  | SI DevOps | SI Test | SIT | 5.0 | Simon Berry | Systems Integration Testing (SIT) | Complete | COMPLETE |  |  |  |  |
| 545 | 1.4.1.2.1.1.5 | Implementation |  | 1d | 2023-10-23 A | 2023-10-23 A | 544FS+85d | 100% |  | 2023-10-23 | 2023-10-23 | 1d | 2023-06-30 | 2023-06-30 |  |  |  | SI DevOps | PPC | SIT | 5.0 | Simon Berry | Systems Integration Testing (SIT) | Complete | COMPLETE |  |  |  |  |

Notes:
- 522: Action: 1280 DIP available for Onboarding (need to add a link - non sit ldso)

| ID | WBS | Task | Duration | Start | Finish | Predecessors | Complete | Baseline start | Baseline finish | Baseline duration | Baseline 1 start | Baseline 1 finish | Constraint | Responsible | Involved | Text9 | Update Version | MHHS Resource Name | MHHS Programme Phase | Sched Status | RAG | Task Status |
| --- | --- | --- | --- | --- | --- | --- | --- | --- | --- | --- | --- | --- | --- | --- | --- | --- | --- | --- | --- | --- | --- | --- |
| 546 | 1.4.1.2.1.2 | **Test Management Tool User Guide** | 115d | 2023-01-02 A | 2023-06-09 A |  | 100% | 2023-01-02 | 2023-06-09 | 115d | 2023-01-02 | 2023-06-09 |  | N/A | N/A | SIT | 5.0 | N/A | Systems Integration Testing (SIT) |  |  |  |
| 547 | 1.4.1.2.1.2.1 | Develop document | 100d | 2023-01-02 A | 2023-05-19 A | 542SS, 543SS | 100% | 2023-01-02 | 2023-05-19 | 100d | 2023-01-02 | 2023-05-19 | start no earlier than 2023-01-02 | SI DevOps |  | SIT | 5.0 |  | Systems Integration Testing (SIT) | Complete | COMPLETE |  |
| 548 | 1.4.1.2.1.2.2 | Review, update and agree Test Management Tool User Guide internally | 15d | 2023-05-22 A | 2023-06-09 A | 547 | 100% | 2023-05-22 | 2023-06-09 | 15d | 2023-05-22 | 2023-06-09 |  | SRO Function | SI DevOps,SI Test,IPA,PPC | SIT | 5.0 |  | Systems Integration Testing (SIT) | Complete | COMPLETE |  |
| 549 | 1.4.1.2.1.3 | **Test Management Tool Configuration Guide** | 60d | 2023-01-02 A | 2023-03-24 A |  | 100% | 2023-01-02 | 2023-03-24 | 60d | 2023-01-02 | 2023-03-24 |  | N/A | N/A | SIT | 5.0 | N/A | Systems Integration Testing (SIT) |  |  |  |
| 550 | 1.4.1.2.1.3.1 | Develop document | 45d | 2023-01-02 A | 2023-03-03 A | 541 | 100% | 2023-01-02 | 2023-03-03 | 45d | 2023-01-02 | 2023-03-03 | start no earlier than 2023-01-02 | SI DevOps | SI Test,IPA | SIT | 5.0 |  | Systems Integration Testing (SIT) | Complete | COMPLETE |  |
| 551 | 1.4.1.2.1.3.2 | Review, update and agree Test Management Tool Configuration Guide internally | 15d | 2023-03-06 A | 2023-03-24 A | 550 | 100% | 2023-03-06 | 2023-03-24 | 15d | 2023-03-06 | 2023-03-24 |  | SRO Function | SI DevOps,SI Test,IPA | SIT | 5.0 |  | Systems Integration Testing (SIT) | Complete | COMPLETE |  |
| 552 | 1.4.1.2.2 | **Secure Volunteer SIT Participants** | 163d? | 2023-01-31 A | 2023-09-14 A |  | 100% | 2023-01-31 | 2023-09-14 | 0d |  |  |  |  |  | SIT | 6.0 |  |  | Overdue Start |  | -680.67 |
| 553 | 1.4.1.2.2.1 | PPs decide whether to volunteer to participate in SIT and inform Programme of decision via Round 3 Replan consultation | 1d? | 2023-01-31 A | 2023-01-31 A |  | 100% | 2023-01-31 | 2023-01-31 | 0d |  |  | finish no earlier than 2023-01-31 | SI Test |  | SIT | 6.0 |  |  | Complete | COMPLETE |  |
| 554 | 1.4.1.2.2.2 | Assurance of SIT volunteers' plans (submitted via Round 3 Replan Consultation) | 1d? | 2023-02-14 A | 2023-02-14 A |  | 100% | 2023-02-14 | 2023-02-14 | 0d |  |  | finish no earlier than 2023-02-14 | SI Test |  | SIT | 6.0 |  |  | Complete | COMPLETE |  |
| 555 | 1.4.1.2.2.3 | SIT Participant Volunteers Identified | 1d? | 2023-02-14 A | 2023-02-14 A |  | 100% | 2023-02-14 | 2023-02-14 | 0d |  |  | start no earlier than 2023-02-14 | SI Test |  | SIT | 6.0 |  |  | Complete | COMPLETE |  |
| 556 | 1.4.1.2.2.4 | Engagement with SIT volunteers | 1d? | 2023-05-23 A | 2023-05-23 A |  | 100% | 2023-05-23 | 2023-05-23 | 0d |  |  | finish no earlier than 2023-05-23 | SI Test |  | SIT | 6.0 |  |  | Complete | COMPLETE |  |
| 557 | 1.4.1.2.2.5 | SIT Participants Agreed | 1d? | 2023-05-23 A | 2023-05-23 A |  | 100% | 2023-05-23 | 2023-05-23 | 0d |  |  | start no earlier than 2023-05-23 | SI Test |  | SIT | 6.0 |  |  | Complete | COMPLETE |  |
| 558 | 1.4.1.2.2.6 | **Data Protection Impact Assessment (DPIA)** | 11d? | 2023-06-30 A | 2023-07-14 A |  | 100% | 2023-06-30 | 2023-07-14 | 0d |  |  |  | SI Test |  | SIT | 6.0 |  |  | Overdue Start |  | -680.67 |
| 559 | 1.4.1.2.2.6.1 | Conduct DPIA on Overall Test Data Approach | 1d? | 2023-06-30 A | 2023-06-30 A |  | 100% | 2023-06-30 | 2023-06-30 | 0d |  |  | finish no earlier than 2023-06-30 | SI Test |  | SIT | 6.0 |  |  | Complete | COMPLETE |  |
| 560 | 1.4.1.2.2.6.2 | Revise Overarching Test Data Approach& plan for DPIA (if required), including engagement with DWG | 1d? | 2023-07-13 A | 2023-07-13 A |  | 100% | 2023-07-13 | 2023-07-13 | 0d |  |  | finish no earlier than 2023-07-13 | SI Test |  | SIT | 6.0 |  |  | Complete | COMPLETE |  |
| 561 | 1.4.1.2.2.6.3 | Review (internal), update and approve revised Overarching Test Data Approach& Plan (if required) | 1d? | 2023-07-14 A | 2023-07-14 A |  | 100% | 2023-07-14 | 2023-07-14 | 0d |  |  | start no earlier than 2023-07-14 | SI Test |  | SIT | 6.0 |  |  | Complete | COMPLETE |  |
| 562 | 1.4.1.2.2.7 | **Data Sharing Agreements** | 30d? | 2023-08-04 A | 2023-09-14 A |  | 100% | 2023-08-04 | 2023-09-14 | 0d |  |  |  | SI Test |  | SIT | 6.0 |  |  | Overdue Start | COMPLETE | -680.67 |
| 563 | 1.4.1.2.2.7.1 | Produce Data Sharing Agreement for Industry Review | 1d? | 2023-08-04 A | 2023-08-04 A |  | 100% | 2023-08-04 | 2023-08-04 | 0d |  |  | finish no earlier than 2023-08-04 | SI Test |  | SIT | 6.0 |  |  | Complete | COMPLETE |  |
| 564 | 1.4.1.2.2.7.2 | Manage Participant Queries and Contract Agreement Execution | 1d? | 2023-09-14 A | 2023-09-14 A |  | 100% | 2023-09-14 | 2023-09-14 | 0d |  |  | finish no earlier than 2023-09-14 | SI Test |  | SIT | 6.0 |  |  | Complete | COMPLETE |  |
| 565 | 1.4.1.2.2.7.3 | Data Sharing Agreements Complete | 1d? | 2023-09-14 A | 2023-09-14 A |  | 100% | 2023-09-14 | 2023-09-14 | 0d |  |  | start no earlier than 2023-09-14 | SI Test |  | SIT | 6.0 |  |  | Complete | COMPLETE |  |
| 566 | 1.4.1.2.2.8 | **Production Data Cut & Data Obfuscation** | 55d? | 2023-06-19 A | 2023-09-01 A |  | 100% | 2023-06-19 | 2023-09-01 | 0d |  |  |  |  |  | SIT | 6.0 |  |  | Overdue Start | COMPLETE | -680.67 |
| 567 | 1.4.1.2.2.8.1 | **SI Data Cut Preparation& Infrastructure** | 45d? | 2023-06-19 A | 2023-08-18 A |  | 100% | 2023-06-19 | 2023-08-18 | 0d |  |  |  |  |  | SIT | 6.0 |  |  | Overdue Start | COMPLETE | -680.67 |
| 568 | 1.4.1.2.2.8.1.1 | SI Data Cut Planning activities (incl. pre-cut and post-cut cleansing and population approach) | 1d? | 2023-06-19 A | 2023-06-19 A |  | 100% | 2023-06-19 | 2023-06-19 | 0d |  |  | finish no earlier than 2023-06-19 |  |  | SIT | 6.0 |  |  | Complete | COMPLETE |  |
| 569 | 1.4.1.2.2.8.1.2 | Set up SI database and transmission structure | 1d? | 2023-08-17 A | 2023-08-17 A |  | 100% | 2023-08-17 | 2023-08-17 | 0d |  |  | finish no earlier than 2023-08-17 |  |  | SIT | 6.0 |  |  | Complete | COMPLETE |  |
| 570 | 1.4.1.2.2.8.1.3 | Mechanism for transfer of data in place | 1d? | 2023-08-18 A | 2023-08-18 A |  | 100% | 2023-08-18 | 2023-08-18 | 0d |  |  | start no earlier than 2023-08-18 |  |  | SIT | 6.0 |  |  | Complete | COMPLETE |  |
| 571 | 1.4.1.2.2.8.1.4 | SI Data Cut Preparation& Infrastructure Complete | 1d? | 2023-08-18 A | 2023-08-18 A |  | 100% | 2023-08-18 | 2023-08-18 | 0d |  |  | start no earlier than 2023-08-18 |  |  | SIT | 6.0 |  |  | Complete | COMPLETE |  |

| ID | WBS | Task | Type | Duration | Start | Finish | Predecessors | Complete | Remaining | Baseline start | Baseline finish | Baseline duration | Baseline 1 start | Baseline 1 finish | Total slack | Constraint | Baseline cost | Text9 | Task Status | Update Version | Sched Status | RAG | Responsible | Involved | MHHS Resource Name | MHHS Programme Phase | Milestone ID | Text29 | Tier | Artefact ID |
| --- | --- | --- | --- | --- | --- | --- | --- | --- | --- | --- | --- | --- | --- | --- | --- | --- | --- | --- | --- | --- | --- | --- | --- | --- | --- | --- | --- | --- | --- | --- |
| 572 | 1.4.1.2.2.8.2 | **Production Data Cut** |  | 55d? | 2023-06-19 A | 2023-09-01 A |  | 100% |  | 2023-06-19 | 2023-09-01 | 0d |  |  |  |  |  | SIT | -680.67 | 6.0 | Overdue Start | COMPLETE |  |  |  |  |  |  |  |  |
| 573 | 1.4.1.2.2.8.2.1 | Notification of Production Data Cut issued to relevant participants |  | 1d? | 2023-06-19 A | 2023-06-19 A |  | 100% |  | 2023-06-19 | 2023-06-19 | 0d |  |  |  | start no earlier than 2023-06-19 |  | SIT |  | 6.0 | Complete | COMPLETE |  |  |  |  |  |  |  |  |
| 574 | 1.4.1.2.2.8.2.2 | Coordinate relevant participants taking data cut from production systems |  | 1d? | 2023-08-11 A | 2023-08-11 A |  | 100% |  | 2023-08-11 | 2023-08-11 | 0d |  |  |  | finish no earlier than 2023-08-11 |  | SIT |  | 6.0 | Complete | COMPLETE |  |  |  |  |  |  |  |  |
| 575 | 1.4.1.2.2.8.2.3 | Production data cut GONG decision |  | 1d? | 2023-08-16 A | 2023-08-16 A |  | 100% |  | 2023-08-16 | 2023-08-16 | 0d |  |  |  | start no earlier than 2023-08-16 |  | SIT |  | 6.0 | Complete | COMPLETE |  |  |  |  |  |  |  |  |
| 576 | 1.4.1.2.2.8.2.4 | Relevant participants take data cut from production systems (Saturday 19 August) |  | 1d? | 2023-08-21 A | 2023-08-21 A |  | 100% |  | 2023-08-21 | 2023-08-21 | 0d |  |  |  | start no earlier than 2023-08-21 |  | SIT |  | 6.0 | Complete | COMPLETE |  |  |  |  |  |  |  |  |
| 577 | 1.4.1.2.2.8.2.5 | EES transmit request data to SI |  | 1d? | 2023-08-25 A | 2023-08-25 A |  | 100% |  | 2023-08-25 | 2023-08-25 | 0d |  |  |  | finish no earlier than 2023-08-25 |  | SIT |  | 6.0 | Complete | COMPLETE |  |  |  |  |  |  |  |  |
| 578 | 1.4.1.2.2.8.2.6 | Check data alignment and integrity of data cut |  | 1d? | 2023-09-01 A | 2023-09-01 A |  | 100% |  | 2023-09-01 | 2023-09-01 | 0d |  |  |  | finish no earlier than 2023-09-01 |  | SIT |  | 6.0 | Complete | COMPLETE |  |  |  |  |  |  |  |  |
| 579 | 1.4.1.2.2.8.2.7 | Data cut from relevant participants' production systems completed (Saturday 19 August) |  | 1d? | 2023-08-21 A | 2023-08-21 A |  | 100% |  | 2023-08-21 | 2023-08-21 | 0d |  |  |  | start no earlier than 2023-08-21 |  | SIT |  | 6.0 | Complete | COMPLETE |  |  |  |  |  |  |  |  |
| 580 | 1.4.1.2.2.8.2.8 | Production Data Cut Complete |  | 1d? | 2023-08-21 A | 2023-08-21 A |  | 100% |  | 2023-08-21 | 2023-08-21 | 0d |  |  |  | start no earlier than 2023-08-21 |  | SIT |  | 6.0 | Complete | COMPLETE |  |  |  |  |  |  |  |  |
| 581 | 1.4.1.3 | **SIT Participation** |  | 147d | 2022-10-31 A | 2023-05-23 A |  | 100% |  | 2022-10-31 | 2023-05-23 | 147d | 2022-10-31 | 2023-05-23 |  |  |  | SIT |  | 5.0 |  |  | N/A | N/A | N/A | Systems Integration Testing (SIT) |  |  |  |  |
| 582 | 1.4.1.3.1 | PPs decide whether to volunteer to participate in SIT and inform Programme of decision via Round 3 Replan consultation |  | 67d | 2022-10-31 A | 2023-01-31 A | 34FF | 100% |  | 2022-10-31 | 2023-01-31 | 67d | 2022-10-31 | 2023-01-31 |  |  |  | SIT |  | 5.0 | Complete | COMPLETE | PP | SI Test,PMO |  | Systems Integration Testing (SIT) |  |  |  |  |
| 583 | 1.4.1.3.2 | Assurance of SIT volunteers' plans (submitted via Round 3 Replan Consultation) |  | 10d | 2023-02-01 A | 2023-02-14 A | 582, 34 | 100% |  | 2023-02-01 | 2023-02-14 | 10d | 2023-02-01 | 2023-02-14 |  |  |  | SIT |  | 5.0 | Complete | COMPLETE | SI Test | PP |  | Systems Integration Testing (SIT) |  |  |  |  |
| 584 | 1.4.1.3.3 | SIT Participant Volunteers Identified | milestone | 0d | 2023-02-14 A | 2023-02-14 A | 583FF | 100% |  | 2023-02-14 | 2023-02-14 | 0d | 2023-02-14 | 2023-02-14 |  |  |  | SIT |  | 5.0 | Complete | COMPLETE | SI Test | PP |  | Systems Integration Testing (SIT) | T2-TE-0100 | SITAG | T2 |  |
| 585 | 1.4.1.3.4 | Engagement with SIT volunteers |  | 147d | 2022-10-31 A | 2023-05-23 A |  | 100% |  | 2022-10-31 | 2023-05-23 | 147d | 2022-10-31 | 2023-05-23 |  |  |  | SIT |  | 5.0 | Complete | COMPLETE | SI Test | PP |  | Systems Integration Testing (SIT) |  |  |  |  |
| 586 | 1.4.1.3.5 | SIT Participants Agreed | milestone | 0d | 2023-05-23 A | 2023-05-23 A | 585, 620FS-74d | 100% |  | 2023-05-23 | 2023-05-23 | 0d | 2023-05-23 | 2023-05-23 |  |  |  | SIT |  | 5.0 | Complete | COMPLETE | SI Test | PP |  | Systems Integration Testing (SIT) | T2-TE-0150 | SITAG | T2 |  |
| 587 | 1.4.1.4 | **SIT Stage-Specific Preparation** |  | 665d? | 2022-10-31 A | 2025-05-16 |  | 79% | 139.22d? | 2022-10-31 | 2025-05-16 | 611d | 2022-10-31 | 2025-03-10 | 679d |  | -0 | SIT |  | 5.0 |  |  | N/A | N/A | N/A | Systems Integration Testing (SIT) |  | SITAG |  |  |
| 588 | 1.4.1.4.1 | **SIT Component Integration Preparation** |  | 320d | 2022-10-31 A | 2024-01-19 A |  | 100% |  | 2022-10-31 | 2024-01-19 | 321d | 2022-10-31 | 2024-01-22 |  |  | -0 | SIT |  | 5.0 |  |  | N/A | N/A | N/A | Systems Integration Testing (SIT) |  |  |  |  |
| 589 | 1.4.1.4.1.1 | **Test Approach & Plan** |  | 188d | 2022-10-31 A | 2023-07-19 A |  | 100% |  | 2022-10-31 | 2023-07-19 | 188d | 2022-10-31 | 2023-07-19 |  |  |  | SIT |  | 5.0 |  |  | N/A | N/A | N/A | Systems Integration Testing (SIT) |  |  |  |  |
| 590 | 1.4.1.4.1.1.1 | Develop document with SITWG |  | 159d | 2022-10-31 A | 2023-06-08 A |  | 100% |  | 2022-10-31 | 2023-06-08 | 159d | 2022-10-31 | 2023-05-12 |  |  |  | SIT |  | 5.0 | Complete | COMPLETE | SI Test |  |  | Systems Integration Testing (SIT) |  |  |  |  |
| 591 | 1.4.1.4.1.1.2 | Industry consultation |  | 10d | 2023-06-09 A | 2023-06-22 A | 590 | 100% |  | 2023-06-09 | 2023-06-22 | 10d |  |  |  |  |  | SIT |  | 5.1 | Complete | COMPLETE | PP |  |  | Systems Integration Testing (SIT) |  |  |  |  |
| 592 | 1.4.1.4.1.1.3 | Artefact review (via TMAG) and updates |  | 19d | 2023-06-23 A | 2023-07-19 A | 591 | 100% |  | 2023-06-23 | 2023-07-19 | 19d | 2023-06-09 | 2023-07-06 |  | finish no earlier than 2023-07-06 |  | SIT |  | 5.0 | Complete | COMPLETE | SI Test | PP,IPA,Code Bodies |  | Systems Integration Testing (SIT) |  |  |  |  |
| 593 | 1.4.1.4.1.1.4 | SIT Component Integration Testing Test Approach & Plan approved | milestone | 0d | 2023-07-19 A | 2023-07-19 A | 592 | 100% |  | 2023-07-19 | 2023-07-19 | 0d | 2023-07-19 | 2023-07-19 |  | finish no earlier than 2023-07-19 |  | SIT |  | 5.0 | Complete | COMPLETE | SI Test | PP |  | Systems Integration Testing (SIT) | T3-TE-0012 | SITAG | T3 | MHHS-ART073 |
| 594 | 1.4.1.4.1.2 | **Test Data Approach & Plan** |  | 29d | 2023-06-09 A | 2023-07-19 A |  | 100% |  | 2023-06-09 | 2023-07-19 | 29d | 2023-06-09 | 2023-07-19 |  |  |  | SIT |  | 5.0 |  |  | N/A | N/A | N/A | Systems Integration Testing (SIT) |  |  |  |  |
| 595 | 1.4.1.4.1.2.1 | Industry consultation |  | 10d | 2023-06-09 A | 2023-06-22 A | 591SS | 100% |  | 2023-06-09 | 2023-06-22 | 10d |  |  |  |  |  | SIT |  | 5.1 | Complete | COMPLETE | PP |  | Cesar Lopes | Systems Integration Testing (SIT) |  |  |  |  |
| 596 | 1.4.1.4.1.2.2 | Artefact review (via TMAG) and updates |  | 19d | 2023-06-23 A | 2023-07-19 A | 595 | 100% |  | 2023-06-23 | 2023-07-19 | 19d | 2023-06-09 | 2023-07-06 |  |  |  | SIT |  | 5.0 | Complete | COMPLETE | SI Test | PP | Cesar Lopes | Systems Integration Testing (SIT) |  |  |  |  |
| 597 | 1.4.1.4.1.2.3 | SIT Component Integration Testing Test Data Approach & Plan approved | milestone | 0d | 2023-07-19 A | 2023-07-19 A | 596 | 100% |  | 2023-07-19 | 2023-07-19 | 0d | 2023-07-19 | 2023-07-19 |  |  |  | SIT |  | 5.0 | Complete | COMPLETE | SI Test | IPA | Cesar Lopes | Systems Integration Testing (SIT) |  |  |  |  |

| ID | WBS | Task | Type | Duration | Start | Finish | Predecessors | Complete | Baseline start | Baseline finish | Baseline duration | Baseline 1 start | Baseline 1 finish | Constraint | Baseline cost | Responsible | Involved | Text9 | Update Version | MHHS Resource Name | MHHS Programme Phase | Sched Status | RAG | Artefact ID | Milestone ID | Text29 | Tier | Task Status |
| --- | --- | --- | --- | --- | --- | --- | --- | --- | --- | --- | --- | --- | --- | --- | --- | --- | --- | --- | --- | --- | --- | --- | --- | --- | --- | --- | --- | --- |
| 598 | 1.4.1.4.1.3 | **Test scenarios** |  | 173d | 2023-01-02 A | 2023-08-30 A |  | 100% | 2023-01-02 | 2023-08-30 | 173d | 2023-01-02 | 2023-06-02 |  |  | N/A | N/A | SIT | 5.0 | N/A | Systems Integration Testing (SIT) |  |  |  |  |  |  |  |
| 599 | 1.4.1.4.1.3.1 | Development of test scenarios | milestone | 0d | 2023-01-02 A | 2023-04-28 A | 590SS+45d | 100% | 2023-01-02 | 2023-04-28 | 85d | 2023-01-02 | 2023-04-28 |  |  | SI Test | PP, Code Bodies | SIT | 5.0 |  | Systems Integration Testing (SIT) | Complete | COMPLETE |  |  |  |  |  |
| 600 | 1.4.1.4.1.3.2 | Review test scenarios with SIT Working Group |  | 11d | 2023-02-01 A | 2023-08-09 A | 599SS+22d | 100% | 2023-02-01 | 2023-08-09 | 136d | 2023-02-01 | 2023-05-26 |  |  | SI Test | PP, Code Bodies, IPA | SIT | 5.0 |  | Systems Integration Testing (SIT) | Complete | COMPLETE |  |  |  |  |  |
| 601 | 1.4.1.4.1.3.3 | SIT Component Integration Testing Test scenarios approved | milestone | 0d | 2023-08-30 A | 2023-08-30 A | 600FS+15d | 100% | 2023-08-30 | 2023-08-30 | 0d | 2023-06-02 | 2023-06-02 |  |  | SI Test | PP | SIT | 5.6 |  | Systems Integration Testing (SIT) | Complete | COMPLETE | MHHS-ART148 | T3-TE-0014 | SITAG | T3 |  |
| 602 | 1.4.1.4.1.4 | **Test cases** |  | 160d | 2023-05-01 A | 2023-12-08 A |  | 100% | 2023-05-01 | 2023-12-08 | 160d | 2023-05-01 | 2023-09-01 |  |  | N/A | N/A | SIT | 5.6 | N/A | Systems Integration Testing (SIT) |  |  |  |  |  |  |  |
| 603 | 1.4.1.4.1.4.1 | **SI Test cases** |  | 160d | 2023-05-01 A | 2023-12-08 A |  | 100% | 2023-05-01 | 2023-12-08 | 160d | 2023-05-01 | 2023-09-01 |  |  | N/A | N/A | SIT | 5.6 | N/A | Systems Integration Testing (SIT) |  |  |  |  |  |  |  |
| 604 | 1.4.1.4.1.4.1.1 | **Batch 1 (CIT Intervals 1 and 2)** |  | 110d | 2023-05-01 A | 2023-09-29 A |  | 100% | 2023-05-01 | 2023-09-29 | 110d |  |  |  |  | N/A | N/A | SIT | 5.6 | N/A | Systems Integration Testing (SIT) |  |  |  |  |  |  | -290.67 |
| 605 | 1.4.1.4.1.4.1.1.1 | Develop Test cases |  | 100d | 2023-05-01 A | 2023-09-15 A | 599 | 100% | 2023-05-01 | 2023-09-15 | 100d | 2023-05-01 | 2023-07-28 |  |  | SI Test |  | SIT | 5.6 |  | Systems Integration Testing (SIT) | Complete | COMPLETE |  |  |  |  |  |
| 606 | 1.4.1.4.1.4.1.1.2 | Review Test cases with SIT Working Group |  | 9d | 2023-09-18 A | 2023-09-28 A | 605 | 100% | 2023-09-18 | 2023-09-28 | 9d | 2023-05-26 | 2023-08-25 |  |  | SI Test | PP,IPA | SIT | 5.6 |  | Systems Integration Testing (SIT) | Complete | COMPLETE |  |  |  |  |  |
| 607 | 1.4.1.4.1.4.1.1.3 | SIT Component Integration Testing Test cases Batch 1 (CIT Intervals 1 and 2) approved at ETMAG | milestone | 0d | 2023-09-29 A | 2023-09-29 A | 606FS+1d | 100% | 2023-09-29 | 2023-09-29 | 0d | 2023-09-01 | 2023-09-01 |  |  | SI Test | PP | SIT | 5.6 |  | Systems Integration Testing (SIT) | Complete | COMPLETE | MHHS-ART073 | T3-TE-0069 | SITAG | T3 |  |
| 608 | 1.4.1.4.1.4.1.2 | **Batch 2 (CIT Intervals 3 and 4)** |  | 25d | 2023-10-02 A | 2023-11-03 A |  | 100% | 2023-10-02 | 2023-11-03 | 25d |  |  |  |  | N/A | N/A | SIT | 5.6 | N/A | Systems Integration Testing (SIT) |  |  |  |  |  |  | -290.67 |
| 609 | 1.4.1.4.1.4.1.2.1 | Develop Test cases |  | 15d | 2023-10-02 A | 2023-10-20 A | 607 | 100% | 2023-10-02 | 2023-10-20 | 15d | 2023-05-01 | 2023-07-28 |  |  | SI Test |  | SIT | 5.6 |  | Systems Integration Testing (SIT) | Complete | COMPLETE |  |  |  |  |  |
| 610 | 1.4.1.4.1.4.1.2.2 | Review Test cases with SIT Working Group |  | 9d | 2023-10-23 A | 2023-11-02 A | 609 | 100% | 2023-10-23 | 2023-11-02 | 9d | 2023-05-26 | 2023-08-25 |  |  | SI Test | PP,IPA | SIT | 5.6 |  | Systems Integration Testing (SIT) | Complete | COMPLETE |  |  |  |  |  |
| 611 | 1.4.1.4.1.4.1.2.3 | SIT Component Integration Testing Test cases Batch 2 (CIT Intervals 3 and 4) approved at ETMAG | milestone | 0d | 2023-11-03 A | 2023-11-03 A | 610FS+1d | 100% | 2023-11-03 | 2023-11-03 | 0d | 2023-09-01 | 2023-09-01 |  |  | SI Test | PP | SIT | 5.11 |  | Systems Integration Testing (SIT) | Complete | COMPLETE |  | T3-TE-0104 | SITAG | T3 |  |
| 612 | 1.4.1.4.1.4.1.3 | **Batch 3 (CIT Intervals 5 and 6)** |  | 25d | 2023-11-03 A | 2023-12-08 A |  | 100% | 2023-11-03 | 2023-12-08 | 25d |  |  |  |  | N/A | N/A | SIT | 5.6 | N/A | Systems Integration Testing (SIT) |  |  |  |  |  |  | -290.67 |
| 613 | 1.4.1.4.1.4.1.3.1 | Develop Test cases |  | 15d | 2023-11-03 A | 2023-11-24 A | 611 | 100% | 2023-11-03 | 2023-11-24 | 15d | 2023-05-01 | 2023-07-28 |  |  | SI Test |  | SIT | 5.6 |  | Systems Integration Testing (SIT) | Complete | COMPLETE |  |  |  |  |  |
| 614 | 1.4.1.4.1.4.1.3.2 | Review Test cases with SIT Working Group |  | 9d | 2023-11-27 A | 2023-12-07 A | 613 | 100% | 2023-11-27 | 2023-12-07 | 9d | 2023-05-26 | 2023-08-25 |  |  | SI Test | PP,IPA | SIT | 5.6 |  | Systems Integration Testing (SIT) | Complete | COMPLETE |  |  |  |  |  |
| 615 | 1.4.1.4.1.4.1.3.3 | SIT Component Integration Testing Test cases Batch 3 (CIT Intervals 5 and 6) approved at ETMAG | milestone | 0d | 2023-12-08 A | 2023-12-08 A | 614FS+1d | 100% | 2023-12-08 | 2023-12-08 | 0d | 2023-09-01 | 2023-09-01 |  |  | SI Test | PP | SIT | 5.14 |  | Systems Integration Testing (SIT) | Complete | COMPLETE |  | T3-TE-0105 | SITAG | T3 |  |
| 616 | 1.4.1.4.1.5 | **CIT Interval 1 Preparation** |  | 283d | 2022-11-16 A | 2023-12-15 A |  | 100% | 2022-11-16 | 2023-12-15 | 278d | 2022-11-16 | 2023-10-23 |  | -0 | N/A | N/A | SIT | 5.6 | N/A | Systems Integration Testing (SIT) |  |  |  |  |  |  |  |
| 617 | 1.4.1.4.1.5.1 | **Environments (SIT A)** |  | 246d | 2022-11-16 A | 2023-10-25 A |  | 100% | 2022-11-16 | 2023-10-25 | 239d | 2022-11-16 | 2023-10-06 |  |  | N/A | N/A | SIT | 5.0 | N/A | Systems Integration Testing (SIT) |  |  |  |  |  |  |  |
| 618 | 1.4.1.4.1.5.1.1 | PPs register PKI Officers and request PKI certificates |  | 5d | 2023-10-09 A | 2023-10-13 A |  | 100% | 2023-10-09 | 2023-10-13 | 5d | 2023-08-28 | 2023-09-01 | start no earlier than 2023-10-09 |  | PP | DIP Provider | SIT | 5.5 | Simon Berry | Systems Integration Testing (SIT) | Complete | COMPLETE |  |  |  |  |  |
| 619 | 1.4.1.4.1.5.1.2 | PPs register PKI Officers and request PKI certificates Complete - Interval 1 | milestone | 0d | 2023-10-25 A | 2023-10-25 A | 618FS+8d | 100% | 2023-10-25 | 2023-10-25 | 0d |  |  |  |  | PP | DIP Provider | SIT | 5.10 | Simon Berry | Systems Integration Testing (SIT) | Complete | COMPLETE |  | T3-TE-0094 | SITAG | T3 |  |
| 620 | 1.4.1.4.1.5.1.3 | PP SIT A environment preparation (incl. security certificates and security compliance) |  | 238d | 2022-11-16 A | 2023-10-13 A | 509 | 100% | 2022-11-16 | 2023-10-13 | 208d | 2022-11-16 | 2023-09-01 |  |  | PP | SI Test | SIT | 5.8 | Simon Berry | Systems Integration Testing (SIT) | Complete | COMPLETE |  |  |  |  |  |
| 621 | 1.4.1.4.1.5.1.4 | SI coordinate SIT Participants' SIT A environment preparation |  | 238d | 2022-11-16 A | 2023-10-13 A | 620SS | 100% | 2022-11-16 | 2023-10-13 | 208d | 2022-11-16 | 2023-09-01 |  |  | SI Test | PP | SIT | 5.8 | Simon Berry | Systems Integration Testing (SIT) | Complete | COMPLETE |  |  |  |  |  |
| 622 | 1.4.1.4.1.5.1.5 | PP submit self-declaration of environment preparation complete (incl. security certificates and security compliance) to Programme for assurance | milestone | 0d | 2023-10-13 A | 2023-10-13 A | 620FF | 100% | 2023-10-13 | 2023-10-13 | 0d | 2023-09-01 | 2023-09-01 | start no earlier than 2023-10-13 |  | PP | SI Test | SIT | 5.8 | Simon Berry | Systems Integration Testing (SIT) | Complete | COMPLETE |  |  |  |  |  |
| 623 | 1.4.1.4.1.5.1.6 | SI assure PPs' self-declaration of environment preparation complete (incl. security certificates and security compliance) |  | 5d | 2023-10-16 A | 2023-10-20 A | 622FF+5d | 100% | 2023-10-16 | 2023-10-20 | 5d | 2023-09-04 | 2023-09-08 |  |  | SI Test | PP | SIT | 5.8 | Simon Berry | Systems Integration Testing (SIT) | Complete | COMPLETE |  |  |  |  |  |
| 624 | 1.4.1.4.1.5.1.7 | SIT Participants' SIT A environments ready to start connectivity proving CIT Interval 1 | milestone | 0d | 2023-09-01 A | 2023-09-01 A | 622SS | 100% | 2023-09-01 | 2023-09-01 | 0d | 2023-09-01 | 2023-09-01 |  |  | PP | PP,IPA | SIT | 5.6 | Simon Berry | Systems Integration Testing (SIT) | Complete | COMPLETE | MHHS-ART139 | T3-TE-0019 | SITAG | T3 |  |
| 625 | 1.4.1.4.1.5.1.8 | PP SIT A environment connectivity proving |  | 10d | 2023-09-04 A | 2023-09-15 A | 624 | 100% | 2023-09-04 | 2023-09-15 | 20d | 2023-09-04 | 2023-09-29 |  |  | PP | SI Test | SIT | 5.8 | Simon Berry | Systems Integration Testing (SIT) | Complete | COMPLETE |  |  |  |  |  |
| 626 | 1.4.1.4.1.5.1.9 | SI coordinate SIT Participants' SIT A environment connectivity proving |  | 10d | 2023-09-04 A | 2023-09-15 A | 625SS | 100% | 2023-09-04 | 2023-09-15 | 20d | 2023-09-04 | 2023-09-29 |  |  | SI Test | PP | SIT | 5.8 | Simon Berry | Systems Integration Testing (SIT) | Complete | COMPLETE |  |  |  |  |  |
| 627 | 1.4.1.4.1.5.1.10 | PP deployment of MHHS solution code to SIT A environments |  | 10d | 2023-09-25 A | 2023-10-06 A | 668FF | 100% | 2023-09-25 | 2023-10-06 | 10d | 2023-09-18 | 2023-09-29 |  |  | PP | SI Test | SIT | 5.0 | Simon Berry | Systems Integration Testing (SIT) | Complete | COMPLETE |  |  |  |  |  |
| 628 | 1.4.1.4.1.5.1.11 | SI coordinate deployment of MHHS solution code to SIT Participants' SIT A environments |  | 10d | 2023-09-25 A | 2023-10-06 A | 668FF | 100% | 2023-09-25 | 2023-10-06 | 10d | 2023-09-18 | 2023-09-29 |  |  | SI Test | PP | SIT | 5.0 | Simon Berry | Systems Integration Testing (SIT) | Complete | COMPLETE |  |  |  |  |  |
| 629 | 1.4.1.4.1.5.1.12 | PP submit evidence of SIT A environment connectivity proving and code deployment completion to Programme for assurance |  | 30d | 2023-09-04 A | 2023-10-13 A | 625SS | 100% | 2023-09-04 | 2023-10-13 | 20d | 2023-09-04 | 2023-09-29 |  |  | PP | SI Test | SIT | 5.8 | Simon Berry | Systems Integration Testing (SIT) | Complete | COMPLETE |  |  |  |  |  |
| 630 | 1.4.1.4.1.5.1.13 | SI assurance of SIT Participants' SIT A environment connectivity proving and code deployment completion |  | 25d | 2023-09-18 A | 2023-10-20 A | 629FF+5d | 100% | 2023-09-18 | 2023-10-20 | 25d | 2023-09-04 | 2023-10-06 |  |  | SI Test | PP | SIT | 5.8 | Simon Berry | Systems Integration Testing (SIT) | Complete | COMPLETE |  |  |  |  |  |

Notes:
- 607: Guidance: 18/8 - needs to finish on 29/9 for ETWAG / Action: 18/8 - needs to finish on 29/9 for ETWAG. Update Milestone register after approval
- 611: Guidance: 18/8 - needs to finish on 3/11 for ETWAG / Action: 18/8 - needs to finish on 29/9 for ETWAG
- 615: Guidance: 28/11 - Red because TMAG date has moved from 8/12 to 20/12 due to reduction in Dec TMAGs. No impact. No action

| ID | WBS | Task | Type | Duration | Start | Finish | Predecessors | Complete | Baseline start | Baseline finish | Baseline duration | Baseline cost | Responsible | Involved | Text9 | Task Status | Update Version | MHHS Resource Name | MHHS Programme Phase | Sched Status | RAG | Action | Milestone ID | Text29 | Tier | Artefact ID |
| --- | --- | --- | --- | --- | --- | --- | --- | --- | --- | --- | --- | --- | --- | --- | --- | --- | --- | --- | --- | --- | --- | --- | --- | --- | --- | --- |
| 631 | 1.4.1.4.1.5.2 | **Test Data - ISD Creation** |  | 9d | 2023-08-22 A | 2023-09-01 A |  | 100% | 2023-08-22 | 2023-09-01 | 9d |  | N/A | N/A | SIT | -275.67 | 5.5 | N/A | Systems Integration Testing (SIT) |  |  |  |  |  |  |  |
| 632 | 1.4.1.4.1.5.2.1 | Set-up Market Participants and DIP ID Data |  | 8d | 2023-08-22 A | 2023-08-31 A |  | 100% | 2023-08-22 | 2023-08-31 | 8d |  | SI Test Data | SI Test, DIP, Helix | SIT |  | 5.5 | Cesar Lopes | Systems Integration Testing (SIT) | Complete | COMPLETE |  |  |  |  |  |
| 633 | 1.4.1.4.1.5.2.2 | Distribute ISD Data to Participants |  | 1d | 2023-09-01 A | 2023-09-01 A | 632 | 100% | 2023-09-01 | 2023-09-01 | 1d |  | SI Test Data | SI Test, DIP, Helix | SIT |  | 5.5 | Cesar Lopes | Systems Integration Testing (SIT) | Complete | COMPLETE |  |  |  |  |  |
| 634 | 1.4.1.4.1.5.2.3 | Test Data - ISD Creation Complete | milestone | 0d | 2023-09-01 A | 2023-09-01 A | 633 | 100% | 2023-09-01 | 2023-09-01 | 0d |  | SI Test Data | SI Test, DIP, Helix | SIT |  | 5.5 | Cesar Lopes | Systems Integration Testing (SIT) | Complete | COMPLETE | 3/8 - add as t3 milestones. Awaiting approval at TMAG | T3-TE-0083 | SITAG | T3 |  |
| 635 | 1.4.1.4.1.5.3 | **Test Data - SFTP Onboarding** |  | 70d | 2023-08-21 A | 2023-11-24 A |  | 100% | 2023-08-21 | 2023-11-24 | 70d | -0 | N/A | N/A | SIT | -275.67 | 5.5 | N/A | Systems Integration Testing (SIT) |  |  |  |  |  |  |  |
| 636 | 1.4.1.4.1.5.3.1 | Create Containers and Keys for Participants |  | 3d | 2023-08-21 A | 2023-08-23 A |  | 100% | 2023-08-21 | 2023-08-23 | 3d |  | SI Test Data | SI Test | SIT |  | 5.5 | Cesar Lopes | Systems Integration Testing (SIT) | Complete | COMPLETE |  |  |  |  |  |
| 637 | 1.4.1.4.1.5.3.2 | Share SFTP Access with Participants |  | 5d | 2023-08-24 A | 2023-08-30 A | 636 | 100% | 2023-08-24 | 2023-08-30 | 5d |  | SI Test Data | SI Test, PP | SIT |  | 5.5 | Cesar Lopes | Systems Integration Testing (SIT) | Complete | COMPLETE |  |  |  |  |  |
| 638 | 1.4.1.4.1.5.3.3 | Test SFTP Connectivity |  | 5d | 2023-08-31 A | 2023-09-06 A | 637 | 100% | 2023-08-31 | 2023-09-06 | 5d |  | SI Test Data | SI Test, PP | SIT |  | 5.5 | Cesar Lopes | Systems Integration Testing (SIT) | Complete | COMPLETE |  |  |  |  |  |
| 639 | 1.4.1.4.1.5.3.4 | Test Data - SFTP Onboarding Complete | milestone | 0d | 2023-11-24 A | 2023-11-24 A | 638FS+57d | 100% | 2023-11-24 | 2023-11-24 | 0d |  | SI Test Data | SI Test, PP | SIT |  | 5.13 | Cesar Lopes | Systems Integration Testing (SIT) | Complete | COMPLETE |  | T3-TE-0084 | SITAG | T3 |  |
| 640 | 1.4.1.4.1.5.4 | **Test Data - Provide Sample Files** |  | 10d | 2023-08-21 A | 2023-09-01 A |  | 100% | 2023-08-21 | 2023-09-01 | 10d |  | N/A | N/A | SIT | -275.67 | 5.5 | N/A | Systems Integration Testing (SIT) |  |  |  |  |  |  |  |
| 641 | 1.4.1.4.1.5.4.1 | Generate Sample Files off IF Messages |  | 8d | 2023-08-21 A | 2023-08-30 A |  | 100% | 2023-08-21 | 2023-08-30 | 8d |  | SI Test Data | SI Test | SIT |  | 5.5 | Cesar Lopes | Systems Integration Testing (SIT) | Complete | COMPLETE |  |  |  |  |  |
| 642 | 1.4.1.4.1.5.4.2 | Transmit Sample Files off IF Messages to Participants (More detail needs to be planned for a POC) |  | 2d | 2023-08-31 A | 2023-09-01 A | 641 | 100% | 2023-08-31 | 2023-09-01 | 2d |  | SI Test Data | SI Test | SIT |  | 5.5 | Cesar Lopes | Systems Integration Testing (SIT) | Complete | COMPLETE |  |  |  |  |  |
| 643 | 1.4.1.4.1.5.4.3 | Test Data - Provide Sample Files Complete | milestone | 0d | 2023-09-01 A | 2023-09-01 A | 642 | 100% | 2023-09-01 | 2023-09-01 | 0d |  | SI Test Data | SI Test | SIT |  | 5.5 | Cesar Lopes | Systems Integration Testing (SIT) | Complete | COMPLETE | 3/8 - add as t3 milestones. Awaiting approval at TMAG | T3-TE-0085 | SITAG | T3 |  |
| 644 | 1.4.1.4.1.5.5 | **Test Data - Detailed SIT Data Load Guidance** |  | 65d | 2023-09-07 A | 2023-12-06 A |  | 100% | 2023-09-07 | 2023-12-06 | 62d | -0 | N/A | N/A | SIT | -275.67 | 5.5 | N/A | Systems Integration Testing (SIT) |  |  |  |  |  |  |  |
| 645 | 1.4.1.4.1.5.5.1 | Document Guidance |  | 21d | 2023-09-07 A | 2023-10-05 A | 643FS+3d | 100% | 2023-09-07 | 2023-10-05 | 16d |  | SI Test Data | SI Test | SIT |  | 5.9 | Cesar Lopes | Systems Integration Testing (SIT) | Complete | COMPLETE |  |  |  |  |  |
| 646 | 1.4.1.4.1.5.5.2 | Provide Guidance to PPs |  | 1d | 2023-10-06 A | 2023-10-06 A | 645 | 100% | 2023-10-06 | 2023-10-06 | 1d |  | SI Test Data | SI Test | SIT |  | 5.9 | Cesar Lopes | Systems Integration Testing (SIT) | Complete | COMPLETE |  |  |  |  |  |
| 647 | 1.4.1.4.1.5.5.3 | Test Data - Detailed SIT Functional Data Load Guidance Complete | milestone | 0d | 2023-12-06 A | 2023-12-06 A | 646FS+43d | 100% | 2023-12-06 | 2023-12-06 | 0d |  | SI Test Data | SI Test | SIT |  | 5.13 | Richard Puddephatt | Systems Integration Testing (SIT) | Complete | COMPLETE |  | T3-TE-0095 | SITAG | T3 | MHHS-DEL 1545 |
| 648 | 1.4.1.4.1.5.6 | **Test Data - Population of Data Items for Testing Guidance - Draft** |  | 80d | 2023-08-17 A | 2023-12-06 A |  | 100% | 2023-08-17 | 2023-12-06 | 77d | -0 | N/A | N/A | SIT | -275.67 | 5.5 | N/A | Systems Integration Testing (SIT) |  |  |  |  |  |  |  |
| 649 | 1.4.1.4.1.5.6.1 | Document Guidance - Draft |  | 11d | 2023-08-17 A | 2023-08-31 A | 838 | 100% | 2023-08-17 | 2023-08-31 | 11d |  | SI Test Data | SI Test | SIT |  | 5.6 | Cesar Lopes | Systems Integration Testing (SIT) | Complete | COMPLETE |  |  |  |  |  |
| 650 | 1.4.1.4.1.5.6.2 | Provide Guidance to PPs - Draft |  | 1d | 2023-09-01 A | 2023-09-01 A | 649 | 100% | 2023-09-01 | 2023-09-01 | 1d |  | SI Test Data | SI Test | SIT |  | 5.6 | Cesar Lopes | Systems Integration Testing (SIT) | Complete | COMPLETE |  |  |  |  |  |
| 651 | 1.4.1.4.1.5.6.3 | Test Data - Population of Data Items for Testing Guidance - Draft Complete | milestone | 0d | 2023-12-06 A | 2023-12-06 A | 650FS+68d | 100% | 2023-12-06 | 2023-12-06 | 0d |  | SI Test Data | SI Test | SIT |  | 5.13 | Richard Puddephatt | Systems Integration Testing (SIT) | Complete | COMPLETE |  | T3-TE-0096 | SITAG | T3 | MHHS-DEL 816 |
| 652 | 1.4.1.4.1.5.7 | **Test Data - Population of Data Items for Testing Guidance - Final** |  | 87d | 2023-08-17 A | 2023-12-15 A |  | 100% | 2023-08-17 | 2023-12-15 | 45d |  | N/A | N/A | SIT | -275.67 | 5.5 | N/A | Systems Integration Testing (SIT) |  |  |  |  |  |  |  |
| 653 | 1.4.1.4.1.5.7.1 | Update Document Guidance With PPS Feedback |  | 81d | 2023-08-17 A | 2023-12-07 A | 649SS | 100% | 2023-08-17 | 2023-12-07 | 44d |  | SI Test Data | SI Test | SIT |  | 5.5 | Richard Puddephatt | Systems Integration Testing (SIT) | Complete | COMPLETE |  |  |  |  |  |
| 654 | 1.4.1.4.1.5.7.2 | Provide Final Guidance to PPs |  | 1d | 2023-12-08 A | 2023-12-08 A | 653 | 100% | 2023-12-08 | 2023-12-08 | 1d |  | SI Test Data | SI Test | SIT |  | 5.5 | Richard Puddephatt | Systems Integration Testing (SIT) | Complete | COMPLETE |  |  |  |  |  |
| 655 | 1.4.1.4.1.5.7.3 | Test Data - Population of Data Items for Testing Guidance - Final Complete | milestone | 0d | 2023-12-15 A | 2023-12-15 A | 654FS+5d | 100% | 2023-12-15 | 2023-12-15 | 0d |  | SI Test Data | SI Test | SIT |  | 5.14 | Richard Puddephatt | Systems Integration Testing (SIT) | Complete | COMPLETE |  | T3-TE-0097 | SITAG | T3 | MHHS-DEL 816 |

| ID | WBS | Task | Type | Duration | Start | Finish | Predecessors | Complete | Baseline start | Baseline finish | Baseline duration | Baseline 1 start | Baseline 1 finish | Constraint | Baseline cost | Responsible | Involved | Text9 | Update Version | MHHS Resource Name | MHHS Programme Phase | Sched Status | RAG | Artefact ID | Milestone ID | Text29 | Tier |
| --- | --- | --- | --- | --- | --- | --- | --- | --- | --- | --- | --- | --- | --- | --- | --- | --- | --- | --- | --- | --- | --- | --- | --- | --- | --- | --- | --- |
| 656 | 1.4.1.4.1.5.8 | **Test Data (SIT A) Interval 1** |  | 40d | 2023-09-04 A | 2023-10-27 A |  | 100% | 2023-09-04 | 2023-10-27 | 20d | 2023-09-04 | 2023-09-29 |  |  | N/A | N/A | SIT | 5.0 | N/A | Systems Integration Testing (SIT) |  |  |  |  |  |  |
| 657 | 1.4.1.4.1.5.8.1 | Run data allocation |  | 4d | 2023-09-04 A | 2023-09-07 A | 597, 634 | 100% | 2023-09-04 | 2023-09-07 | 4d | 2023-09-04 | 2023-09-07 |  |  | SI Test |  | SIT | 5.0 | Cesar Lopes | Systems Integration Testing (SIT) | Complete | COMPLETE |  |  |  |  |
| 658 | 1.4.1.4.1.5.8.2 | Cleanse, anonymise and populate data post cut |  | 4d | 2023-09-08 A | 2023-09-13 A | 657 | 100% | 2023-09-08 | 2023-09-13 | 4d | 2023-09-08 | 2023-09-13 |  |  | SI Test |  | SIT | 5.0 | Cesar Lopes | Systems Integration Testing (SIT) | Complete | COMPLETE |  |  |  |  |
| 659 | 1.4.1.4.1.5.8.3 | Transmit data sets to PPs |  | 3d | 2023-09-15 A | 2023-09-19 A | 658 | 100% | 2023-09-15 | 2023-09-19 | 1d | 2023-09-14 | 2023-09-15 |  |  | SI Test |  | SIT | 5.0 | Cesar Lopes | Systems Integration Testing (SIT) | Complete | COMPLETE |  |  |  |  |
| 660 | 1.4.1.4.1.5.8.4 | PP - Load test data to test environments |  | 7d | 2023-09-20 A | 2023-09-28 A | 659, 643 | 100% | 2023-09-20 | 2023-09-28 | 5d | 2023-09-18 | 2023-09-22 |  |  | PP |  | SIT | 5.0 | Cesar Lopes | Systems Integration Testing (SIT) | Complete | COMPLETE |  |  |  |  |
| 661 | 1.4.1.4.1.5.8.5 | PP Check data integrity on test environment |  | 1d | 2023-09-29 A | 2023-09-29 A | 660 | 100% | 2023-09-29 | 2023-09-29 | 5d | 2023-09-25 | 2023-09-29 |  |  | PP |  | SIT | 5.0 | Cesar Lopes | Systems Integration Testing (SIT) | Complete | COMPLETE |  |  |  |  |
| 662 | 1.4.1.4.1.5.8.6 | PP submit self-declaration to Programme to confirm loading & verification of test data | milestone | 0d | 2023-09-29 A | 2023-09-29 A | 661FF | 100% | 2023-09-29 | 2023-09-29 | 0d | 2023-09-29 | 2023-09-29 |  |  | PP | SI Test | SIT | 5.0 | Cesar Lopes | Systems Integration Testing (SIT) | Complete | COMPLETE |  |  |  |  |
| 663 | 1.4.1.4.1.5.8.7 | Test Data (SIT A) Interval 1 Complete | milestone | 0d | 2023-10-27 A | 2023-10-27 A | 662FS+20d | 100% | 2023-10-27 | 2023-10-27 | 0d |  |  |  |  | SI Test | PP | SIT | 5.10 | Cesar Lopes | Systems Integration Testing (SIT) | Complete | COMPLETE | MHHS-ART148/169 | T3-TE-0073 | SITAG | T3 |
| 664 | 1.4.1.4.1.5.9 | **Other Preparation** |  | 45d | 2023-07-03 A | 2023-09-01 A |  | 100% | 2023-07-03 | 2023-09-01 | 45d | 2023-07-03 | 2023-09-01 |  |  | N/A | N/A | SIT | 5.0 | N/A | Systems Integration Testing (SIT) |  |  |  |  |  |  |
| 665 | 1.4.1.4.1.5.9.1 | Onboarding of Test Participants to Test Management Tool (Azure DevOps) |  | 45d | 2023-07-03 A | 2023-09-01 A | 624SF | 100% | 2023-07-03 | 2023-09-01 | 45d | 2023-07-03 | 2023-09-01 |  |  | SI Test | PP | SIT | 5.0 |  | Systems Integration Testing (SIT) | Complete | COMPLETE |  |  |  |  |
| 666 | 1.4.1.4.1.5.9.2 | Test Management Tool onboarding |  | 45d | 2023-07-03 A | 2023-09-01 A | 624SF | 100% | 2023-07-03 | 2023-09-01 | 45d | 2023-07-03 | 2023-09-01 |  |  | PP | SI Test | SIT | 5.0 |  | Systems Integration Testing (SIT) | Complete | COMPLETE |  |  |  |  |
| 667 | 1.4.1.4.1.5.10 | **SIT Component Integration Test Readiness Report** |  | 28d | 2023-09-14 A | 2023-10-23 A |  | 100% | 2023-09-14 | 2023-10-23 | 9d | 2023-09-11 | 2023-10-20 |  |  | N/A | N/A | SIT | 5.6 | N/A | Systems Integration Testing (SIT) |  |  |  |  |  |  |
| 668 | 1.4.1.4.1.5.10.1 | PP submit Test Readiness Report to Programme for assurance | milestone | 0d | 2023-10-20 A | 2023-10-20 A | 666, 607, 663 | 100% | 2023-10-20 | 2023-10-20 | 0d | 2023-09-29 | 2023-09-29 | start no earlier than 2023-10-09 |  | PP | SI Test | SIT | 5.6 |  | Systems Integration Testing (SIT) | Complete | COMPLETE |  |  |  |  |
| 669 | 1.4.1.4.1.5.10.2 | SI assure Test Participants' Test Readiness Reports |  | 1d | 2023-10-23 A | 2023-10-23 A | 668SS | 100% | 2023-10-23 | 2023-10-23 | 5d | 2023-10-02 | 2023-10-06 |  |  | SI Test | PP,IPA | SIT | 5.6 |  | Systems Integration Testing (SIT) | Complete | COMPLETE |  |  |  |  |
| 670 | 1.4.1.4.1.5.10.3 | SI develop Overarching SIT Component Integration Test Readiness Report |  | 23d | 2023-09-14 A | 2023-10-16 A | 593FS+40d | 100% | 2023-09-14 | 2023-10-16 | 4d | 2023-09-11 | 2023-10-06 |  |  | SI Test |  | SIT | 5.6 |  | Systems Integration Testing (SIT) | Complete | COMPLETE |  |  |  |  |
| 671 | 1.4.1.4.1.5.10.4 | Artefact review (via TMAG) and updates |  | 4d | 2023-10-17 A | 2023-10-20 A | 670 | 100% | 2023-10-17 | 2023-10-20 | 5d | 2023-10-09 | 2023-10-20 |  |  | SI Test | PP,IPA | SIT | 5.6 |  | Systems Integration Testing (SIT) | Complete | COMPLETE |  |  |  |  |
| 672 | 1.4.1.4.1.5.11 | SIT Component Integration Testing 1 Preparation Complete (incl. approval of SI SIT Component Integration Test Readiness Report) | milestone | 0d | 2023-10-27 A | 2023-10-27 A | 671FS+1d, 668, 624, 666, 663, 240, 245, 234, 254, 255, 669 | 100% | 2023-10-27 | 2023-10-27 | 0d | 2023-10-23 | 2023-10-23 |  |  | SI Test | PP,IPA | SIT | 5.11 |  | Systems Integration Testing (SIT) | Complete | COMPLETE | MHHS-ART071 | T2-TE-0250 | SITAG | T2 |
| 673 | 1.4.1.4.1.6 | **CIT Interval 2 Preparation** |  | 103d | 2023-07-03 A | 2023-11-22 A |  | 100% | 2023-07-03 | 2023-11-22 | 95d | 2022-11-16 | 2023-11-06 |  | -0 | N/A | N/A | SIT | 5.0 | N/A | Systems Integration Testing (SIT) |  |  |  |  |  |  |
| 674 | 1.4.1.4.1.6.1 | **Environments (SIT A)** |  | 43d | 2023-09-22 A | 2023-11-22 A |  | 100% | 2023-09-22 | 2023-11-22 | 35d | 2022-11-16 | 2023-10-27 |  | -0 | N/A | N/A | SIT | 5.0 | N/A | Systems Integration Testing (SIT) |  |  |  |  |  |  |
| 675 | 1.4.1.4.1.6.1.1 | SIT Participants' SIT A environments ready to start connectivity proving CIT Interval 2 | milestone | 0d | 2023-09-22 A | 2023-09-22 A |  | 100% | 2023-09-22 | 2023-09-22 | 0d | 2023-09-22 | 2023-09-22 |  |  | PP | PP,IPA | SIT | 5.6 | Simon Berry | Systems Integration Testing (SIT) | Complete | COMPLETE | MHHS-ART139 | T3-TE-0020 | SITAG | T3 |
| 676 | 1.4.1.4.1.6.1.2 | Programme Participants Ready to Start Connectivity Proving | milestone | 0d | 2023-09-22 A | 2023-09-22 A |  | 100% | 2023-09-22 | 2023-09-22 | 0d |  |  | finish no earlier than 2023-09-22 |  | PP |  | SIT | 5.10 | Simon Berry | Systems Integration Testing (SIT) | Complete | COMPLETE |  |  |  |  |
| 677 | 1.4.1.4.1.6.1.3 | Internal Connectivity Proving Phase |  | 10d | 2023-09-25 A | 2023-10-06 A | 676 | 100% | 2023-09-25 | 2023-10-06 | 10d |  |  |  |  | PP |  | SIT | 5.10 | Simon Berry | Systems Integration Testing (SIT) | Complete | COMPLETE |  |  |  |  |
| 678 | 1.4.1.4.1.6.1.4 | Internal Connectivity Proving Phase Complete | milestone | 0d | 2023-10-06 A | 2023-10-06 A | 677 | 100% | 2023-10-06 | 2023-10-06 | 0d |  |  | start no earlier than 2023-10-06 |  | PP |  | SIT | 5.10 | Simon Berry | Systems Integration Testing (SIT) | Complete | COMPLETE |  |  |  |  |
| 679 | 1.4.1.4.1.6.1.5 | DIP Onboarding Activity (1. PKI Officers and Certificates, 2. Set-up Validation, 3. End Point Creation, 4. Controlled Smoke Test ) |  | 28d | 2023-10-16 A | 2023-11-22 A | 678FS+5d | 100% | 2023-10-16 | 2023-11-22 | 20d |  |  |  |  | PP |  | SIT | 5.10 | Simon Berry | Systems Integration Testing (SIT) | Complete | COMPLETE |  |  |  |  |
| 680 | 1.4.1.4.1.6.1.6 | DIP Onboarding Complete | milestone | 0d | 2023-11-22 A | 2023-11-22 A | 679 | 100% | 2023-11-22 | 2023-11-22 | 0d |  |  |  |  | PP |  | SIT | 5.10 | Simon Berry | Systems Integration Testing (SIT) | Complete | COMPLETE |  |  |  |  |
| 681 | 1.4.1.4.1.6.1.7 | PPs Register PKI Officers and request PKI certificates Complete - Interval 2 | milestone | 0d | 2023-11-22 A | 2023-11-22 A | 680 | 100% | 2023-11-22 | 2023-11-22 | 0d |  |  |  |  | PP | DIP Provider | SIT | 5.15 | Simon Berry | Systems Integration Testing (SIT) | Complete | COMPLETE |  | T3-TE-0098 | SITAG | T3 |
| 682 | 1.4.1.4.1.6.1.8 | PP Code Deployment | milestone | 0d | 2023-10-20 A | 2023-10-20 A |  | 100% | 2023-10-20 | 2023-10-20 | 0d |  |  | start no earlier than 2023-10-20 |  | PP |  | SIT | 5.10 | Simon Berry | Systems Integration Testing (SIT) | Complete | COMPLETE |  |  |  |  |

Notes:
- 663: Action: 28/7: CH: Needs to be set-up as a reporting milestone. 31/7: Check with Cesar if has been approved so can be baselined
- 667: Action: 21/8 - Rework with Lee
- 669: Action: 21/8 - Rework with Lee
- 670: Action: 21/8 - Rework with Lee
- 671: Action: 21/8 - Rework with Lee

| ID | WBS | Task | Type | Duration | Start | Finish | Predecessors | Complete | Baseline start | Baseline finish | Baseline duration | Baseline 1 start | Baseline 1 finish | Constraint | Baseline cost | Responsible | Involved | Text9 | Update Version | MHHS Resource Name | MHHS Programme Phase | Sched Status | RAG | Artefact ID | Milestone ID | Text29 | Tier |
| --- | --- | --- | --- | --- | --- | --- | --- | --- | --- | --- | --- | --- | --- | --- | --- | --- | --- | --- | --- | --- | --- | --- | --- | --- | --- | --- | --- |
| 683 | 1.4.1.4.1.6.2 | **Test Data (SIT A) Interval 2** |  | 43d | 2023-09-20 A | 2023-11-17 A |  | 100% | 2023-09-20 | 2023-11-17 | 25d | 2023-09-18 | 2023-10-20 |  |  | N/A | N/A | SIT | 5.0 | N/A | Systems Integration Testing (SIT) |  |  |  |  |  |  |
| 684 | 1.4.1.4.1.6.2.1 | Run data allocation |  | 7d | 2023-09-20 A | 2023-09-28 A | 660SS | 100% | 2023-09-20 | 2023-09-28 | 5d | 2023-09-18 | 2023-09-22 |  |  | SI Test |  | SIT | 5.0 | Cesar Lopes | Systems Integration Testing (SIT) | Complete | COMPLETE |  |  |  |  |
| 685 | 1.4.1.4.1.6.2.2 | Cleanse and populate data post cut |  | 2d | 2023-09-29 A | 2023-10-02 A | 684 | 100% | 2023-09-29 | 2023-10-02 | 5d | 2023-09-25 | 2023-09-29 |  |  | SI Test |  | SIT | 5.0 | Cesar Lopes | Systems Integration Testing (SIT) | Complete | COMPLETE |  |  |  |  |
| 686 | 1.4.1.4.1.6.2.3 | Transmit data sets to PPs |  | 1d | 2023-10-03 A | 2023-10-03 A | 685 | 100% | 2023-10-03 | 2023-10-03 | 2d | 2023-10-02 | 2023-10-03 |  |  | SI Test |  | SIT | 5.0 | Cesar Lopes | Systems Integration Testing (SIT) | Complete | COMPLETE |  |  |  |  |
| 687 | 1.4.1.4.1.6.2.4 | PP - Load test data to test environments |  | 33d | 2023-10-04 A | 2023-11-17 A | 686 | 100% | 2023-10-04 | 2023-11-17 | 8d | 2023-10-04 | 2023-10-13 |  |  | PP |  | SIT | 5.0 | Cesar Lopes | Systems Integration Testing (SIT) | Complete | COMPLETE |  |  |  |  |
| 688 | 1.4.1.4.1.6.2.5 | PP Check data integrity on test environment |  | 15d | 2023-10-23 A | 2023-11-17 A | 687FF | 100% | 2023-10-23 | 2023-11-17 | 5d | 2023-10-16 | 2023-10-20 |  |  | PP |  | SIT | 5.0 | Cesar Lopes | Systems Integration Testing (SIT) | Complete | COMPLETE |  |  |  |  |
| 689 | 1.4.1.4.1.6.2.6 | PP submit self-declaration to Programme to confirm loading & verification of test data | milestone | 0d | 2023-11-17 A | 2023-11-17 A | 688FF | 100% | 2023-11-17 | 2023-11-17 | 0d | 2023-10-20 | 2023-10-20 |  |  | PP | SI Test | SIT | 5.0 | Cesar Lopes | Systems Integration Testing (SIT) | Complete | COMPLETE |  |  |  |  |
| 690 | 1.4.1.4.1.6.2.7 | Test Data (SIT A) Interval 2 Complete | milestone | 0d | 2023-11-17 A | 2023-11-17 A | 689 | 100% | 2023-11-17 | 2023-11-17 | 0d |  |  |  |  | SI Test | PP | SIT | 5.12 | Cesar Lopes | Systems Integration Testing (SIT) | Complete | COMPLETE | MHHS-ART148/169 | T3-TE-0074 | SITAG | T3 |
| 691 | 1.4.1.4.1.6.3 | **Other Preparation** |  | 87d | 2023-07-03 A | 2023-10-31 A |  | 100% | 2023-07-03 | 2023-10-31 | 87d | 2023-07-03 | 2023-09-22 |  | -0 | N/A | N/A | SIT | 5.0 | N/A | Systems Integration Testing (SIT) |  |  |  |  |  |  |
| 692 | 1.4.1.4.1.6.3.1 | Onboarding of Test Participants to Test Management Tool (Azure DevOps) |  | 60d | 2023-07-03 A | 2023-09-22 A | 675SF | 100% | 2023-07-03 | 2023-09-22 | 60d | 2023-07-03 | 2023-09-22 |  |  | SI Test | PP | SIT | 5.0 |  | Systems Integration Testing (SIT) | Complete | COMPLETE |  |  |  |  |
| 693 | 1.4.1.4.1.6.3.2 | Test Management Tool onboarding |  | 27d | 2023-09-25 A | 2023-10-31 A | 692 | 100% | 2023-09-25 | 2023-10-31 | 27d | 2023-07-03 | 2023-09-22 |  |  | PP | SI Test | SIT | 5.0 | Simon Berry | Systems Integration Testing (SIT) | Complete | COMPLETE |  |  |  |  |
| 694 | 1.4.1.4.1.6.4 | **SIT Component Integration Test Readiness Report** |  | 25d | 2023-10-02 A | 2023-11-03 A |  | 100% | 2023-10-02 | 2023-11-03 | 25d | 2023-10-02 | 2023-11-03 |  |  | N/A | N/A | SIT | 5.0 | N/A | Systems Integration Testing (SIT) |  |  |  |  |  |  |
| 695 | 1.4.1.4.1.6.4.1 | PP submit Test Readiness Report to Programme for assurance | milestone | 0d | 2023-10-25 A | 2023-10-25 A | 607FS+18d | 100% | 2023-10-25 | 2023-10-25 | 0d | 2023-10-20 | 2023-10-20 |  |  | PP | SI Test | SIT | 5.0 |  | Systems Integration Testing (SIT) | Complete | COMPLETE |  |  |  |  |
| 696 | 1.4.1.4.1.6.4.2 | SI assure Test Participants' Test Readiness Reports |  | 2d | 2023-10-26 A | 2023-10-27 A | 695 | 100% | 2023-10-26 | 2023-10-27 | 5d | 2023-10-23 | 2023-10-27 |  |  | SI Test | PP,IPA | SIT | 5.0 |  | Systems Integration Testing (SIT) | Complete | COMPLETE |  |  |  |  |
| 697 | 1.4.1.4.1.6.4.3 | SI develop Overarching SIT Component Integration Test Readiness Report |  | 20d | 2023-10-02 A | 2023-10-27 A | 696FF | 100% | 2023-10-02 | 2023-10-27 | 20d | 2023-10-02 | 2023-10-27 |  |  | SI Test |  | SIT | 5.0 |  | Systems Integration Testing (SIT) | Complete | COMPLETE |  |  |  |  |
| 698 | 1.4.1.4.1.6.4.4 | Artefact review (via TMAG) and updates |  | 5d | 2023-10-30 A | 2023-11-03 A | 697 | 100% | 2023-10-30 | 2023-11-03 | 5d | 2023-10-30 | 2023-11-03 |  |  | SI Test | PP,IPA | SIT | 5.0 |  | Systems Integration Testing (SIT) | Complete | COMPLETE |  |  |  |  |
| 699 | 1.4.1.4.1.6.5 | SIT Component Integration Testing 2 Preparation Complete (incl. approval of SI SIT Component Integration Test Readiness Report) | milestone | 0d | 2023-11-06 A | 2023-11-06 A | 693, 698FS+1d, 675, 303 | 100% | 2023-11-06 | 2023-11-06 | 0d | 2023-11-06 | 2023-11-06 |  |  | SI Test | PP,IPA | SIT | 5.11 |  | Systems Integration Testing (SIT) | Complete | COMPLETE | MHHS-ART071 | T2-TE-0300 | SITAG | T2 |
| 700 | 1.4.1.4.1.7 | **CIT Interval 3 Preparation** |  | 54d | 2023-10-03 A | 2023-12-15 A |  | 100% | 2023-10-03 | 2023-12-15 | 91d | 2022-11-16 | 2023-11-20 |  | -0 | N/A | N/A | SIT | 5.0 | N/A | Systems Integration Testing (SIT) |  |  |  |  |  |  |
| 701 | 1.4.1.4.1.7.1 | **PIT Test Completion Report (incl. evidence)** |  | 26d | 2023-10-13 A | 2023-11-17 A |  | 100% | 2023-10-13 | 2023-11-17 | 21d | 2023-10-13 | 2023-11-10 |  |  | N/A | N/A | SIT | 5.0 | N/A | Systems Integration Testing (SIT) |  |  |  |  |  |  |
| 702 | 1.4.1.4.1.7.1.1 | Submit draft PIT Test Completion Report (incl. evidence) and submit to Programme for assurance |  | 11d | 2023-10-13 A | 2023-10-27 A |  | 100% | 2023-10-13 | 2023-10-27 | 1d | 2023-10-13 | 2023-10-13 | must start on 2023-10-13 |  | PP | SI Test | SIT | 5.0 |  | Systems Integration Testing (SIT) | Complete | COMPLETE |  |  |  |  |
| 703 | 1.4.1.4.1.7.1.2 | Finalise PIT Test Completion Report (incl. evidence) |  | 5d | 2023-10-30 A | 2023-11-03 A | 702 | 100% | 2023-10-30 | 2023-11-03 | 15d | 2023-10-16 | 2023-11-03 |  |  | PP | SI Test | SIT | 5.0 |  | Systems Integration Testing (SIT) | Complete | COMPLETE |  |  |  |  |
| 704 | 1.4.1.4.1.7.1.3 | PP PIT Completion Report (excl. Migration/Reverse Migration) submitted to Programme for assurance CIT Interval 3 | milestone | 0d | 2023-11-03 A | 2023-11-03 A | 703, 79, 95 | 100% | 2023-11-03 | 2023-11-03 | 0d | 2023-11-03 | 2023-11-03 |  |  | PP | SI Test | SIT | 5.11 |  | Systems Integration Testing (SIT) | Complete | COMPLETE |  | T3-DB-0017 | SITAG | T3 |
| 705 | 1.4.1.4.1.7.1.4 | PP Final PIT Completion Reports assured by SI |  | 10d | 2023-11-06 A | 2023-11-17 A | 704 | 100% | 2023-11-06 | 2023-11-17 | 5d | 2023-11-06 | 2023-11-10 |  |  | SI Test | PP | SIT | 5.0 |  | Systems Integration Testing (SIT) | Complete | COMPLETE |  |  |  |  |
| 706 | 1.4.1.4.1.7.2 | **Environments (SIT A)** |  | 51d | 2023-10-06 A | 2023-12-15 A |  | 100% | 2023-10-06 | 2023-12-15 | 26d | 2022-11-16 | 2023-11-10 |  | -0 | N/A | N/A | SIT | 5.0 | N/A | Systems Integration Testing (SIT) |  |  |  |  |  |  |
| 707 | 1.4.1.4.1.7.2.1 | Programme Participants Ready to Start Connectivity Proving | milestone | 0d | 2023-10-06 A | 2023-10-06 A |  | 100% | 2023-10-06 | 2023-10-06 | 0d |  |  | start no earlier than 2023-10-06 |  | PP | PP.SI Test | SIT | 5.10 | Simon Berry | Systems Integration Testing (SIT) | Complete | COMPLETE |  |  |  |  |
| 708 | 1.4.1.4.1.7.2.2 | SIT Participants' SIT A environments ready to start connectivity proving CIT Interval 3 | milestone | 0d | 2023-10-06 A | 2023-10-06 A | 707 | 100% | 2023-10-06 | 2023-10-06 | 0d | 2023-10-06 | 2023-10-06 |  |  | PP | PP,SI Test | SIT | 5.10 | Simon Berry | Systems Integration Testing (SIT) | Complete | COMPLETE | MHHS-ART139 | T3-TE-0021 | SITAG | T3 |
| 709 | 1.4.1.4.1.7.2.3 | Internal Connectivity Proving Phase |  | 10d | 2023-10-09 A | 2023-10-20 A | 707FS+1d | 100% | 2023-10-09 | 2023-10-20 | 10d |  |  |  |  | PP | PP,SI Test | SIT | 5.10 | Simon Berry | Systems Integration Testing (SIT) | Complete | COMPLETE |  |  |  |  |
| 710 | 1.4.1.4.1.7.2.4 | Internal Connectivity Proving Phase Complete | milestone | 0d | 2023-10-20 A | 2023-10-20 A | 709 | 100% | 2023-10-20 | 2023-10-20 | 0d |  |  |  |  | PP | PP,SI Test | SIT | 5.10 | Simon Berry | Systems Integration Testing (SIT) | Complete | COMPLETE |  |  |  |  |
| 711 | 1.4.1.4.1.7.2.5 | DIP Onboarding Activity (1. PKI Officers and Certificates, 2. Set-up Validation, 3. End Point Creation, 4. Controlled Smoke Test ) |  | 35d | 2023-10-30 A | 2023-12-15 A | 710FS+5d | 100% | 2023-10-30 | 2023-12-15 | 10d |  |  |  |  | PP | PP,DIP Provider | SIT | 5.10 | Simon Berry | Systems Integration Testing (SIT) | Complete | COMPLETE |  |  |  |  |
| 712 | 1.4.1.4.1.7.2.6 | DIP Onboarding Complete | milestone | 0d | 2023-12-15 A | 2023-12-15 A | 711 | 100% | 2023-12-15 | 2023-12-15 | 0d |  |  |  |  | PP | PP,DIP Provider | SIT | 5.10 | Simon Berry | Systems Integration Testing (SIT) | Complete | COMPLETE |  |  |  |  |
| 713 | 1.4.1.4.1.7.2.7 | PPs Register PKI Officers and Request PKI certificates Complete - Interval 3 | milestone | 0d | 2023-12-15 A | 2023-12-15 A | 712FF | 100% | 2023-12-15 | 2023-12-15 | 0d | 2023-10-02 | 2023-10-06 |  |  | PP | PP,DIP Provider | SIT | 5.13 | Simon Berry | Systems Integration Testing (SIT) | Complete | COMPLETE |  | T3-TE-0099 | SITAG | T3 |
| 714 | 1.4.1.4.1.7.2.8 | PP Code Deployment | milestone | 0d | 2023-11-10 A | 2023-11-10 A | 710FS+15d | 100% | 2023-11-10 | 2023-11-10 | 0d |  |  | start no earlier than 2023-10-20 |  | PP | PP | SIT | 5.10 | Simon Berry | Systems Integration Testing (SIT) | Complete | COMPLETE |  |  |  |  |

Notes:
- 690: Action: 28/7: CH: Needs to be set-up as a reporting milestone. 31/7: Check with Cesar if has been approved so can be baselined
- 708: Action: 30/8 - lee said date is 30/10

| ID | WBS | Task | Type | Duration | Start | Finish | Predecessors | Complete | Baseline start | Baseline finish | Baseline duration | Baseline 1 start | Baseline 1 finish | Constraint | Baseline cost | Responsible | Involved | Text9 | Update Version | MHHS Resource Name | MHHS Programme Phase | Sched Status | RAG | Artefact ID | Milestone ID | Text29 | Tier |
| --- | --- | --- | --- | --- | --- | --- | --- | --- | --- | --- | --- | --- | --- | --- | --- | --- | --- | --- | --- | --- | --- | --- | --- | --- | --- | --- | --- |
| 715 | 1.4.1.4.1.7.3 | **Test Data (SIT A) Interval 3** |  | 34d | 2023-10-03 A | 2023-11-17 A |  | 100% | 2023-10-03 | 2023-11-17 | 25d | 2023-10-02 | 2023-11-03 |  |  | N/A | N/A | SIT | 5.0 | N/A | Systems Integration Testing (SIT) |  |  |  |  |  |  |
| 716 | 1.4.1.4.1.7.3.1 | Run data allocation |  | 4d | 2023-10-03 A | 2023-10-06 A | 686SS | 100% | 2023-10-03 | 2023-10-06 | 5d | 2023-10-02 | 2023-10-06 |  |  | SI Test |  | SIT | 5.0 | Cesar Lopes | Systems Integration Testing (SIT) | Complete | COMPLETE |  |  |  |  |
| 717 | 1.4.1.4.1.7.3.2 | Cleanse and populate data post cut |  | 5d | 2023-10-09 A | 2023-10-13 A | 716 | 100% | 2023-10-09 | 2023-10-13 | 5d | 2023-10-09 | 2023-10-13 |  |  | SI Test |  | SIT | 5.0 | Cesar Lopes | Systems Integration Testing (SIT) | Complete | COMPLETE |  |  |  |  |
| 718 | 1.4.1.4.1.7.3.3 | Transmit data sets to PPs |  | 2d | 2023-10-16 A | 2023-10-17 A | 717 | 100% | 2023-10-16 | 2023-10-17 | 2d | 2023-10-16 | 2023-10-17 |  |  | SI Test |  | SIT | 5.0 | Cesar Lopes | Systems Integration Testing (SIT) | Complete | COMPLETE |  |  |  |  |
| 719 | 1.4.1.4.1.7.3.4 | PP - Load test data to test environments |  | 8d | 2023-10-18 A | 2023-10-27 A | 718 | 100% | 2023-10-18 | 2023-10-27 | 8d | 2023-10-18 | 2023-10-27 |  |  | PP |  | SIT | 5.0 | Cesar Lopes | Systems Integration Testing (SIT) | Complete | COMPLETE |  |  |  |  |
| 720 | 1.4.1.4.1.7.3.5 | PP Check data integrity on test environment |  | 15d | 2023-10-30 A | 2023-11-17 A | 719 | 100% | 2023-10-30 | 2023-11-17 | 5d | 2023-10-30 | 2023-11-03 |  |  | PP |  | SIT | 5.0 | Cesar Lopes | Systems Integration Testing (SIT) | Complete | COMPLETE |  |  |  |  |
| 721 | 1.4.1.4.1.7.3.6 | PP submit self-declaration to Programme to confirm loading & verification of test data | milestone | 0d | 2023-11-17 A | 2023-11-17 A | 720FF | 100% | 2023-11-17 | 2023-11-17 | 0d | 2023-11-03 | 2023-11-03 |  |  | PP | SI Test | SIT | 5.0 | Cesar Lopes | Systems Integration Testing (SIT) | Complete | COMPLETE |  |  |  |  |
| 722 | 1.4.1.4.1.7.3.7 | Test Data (SIT A) Interval 3 Complete | milestone | 0d | 2023-11-17 A | 2023-11-17 A | 721 | 100% | 2023-11-17 | 2023-11-17 | 0d |  |  |  |  | SI Test | PP | SIT | 5.13 | Cesar Lopes | Systems Integration Testing (SIT) | Complete | COMPLETE | MHHS-ART148/169 | T3-TE-0075 | SITAG | T3 |
| 723 | 1.4.1.4.1.7.4 | **Other Preparation** |  | 25d | 2023-10-16 A | 2023-11-17 A |  | 100% | 2023-10-16 | 2023-11-17 | 60d | 2023-07-17 | 2023-10-06 |  |  | N/A | N/A | SIT | 5.0 | N/A | Systems Integration Testing (SIT) |  |  |  |  |  |  |
| 724 | 1.4.1.4.1.7.4.1 | Onboarding of Test Participants to Test Management Tool (Azure DevOps) |  | 25d | 2023-10-16 A | 2023-11-17 A |  | 100% | 2023-10-16 | 2023-11-17 | 60d | 2023-07-17 | 2023-10-06 | start no earlier than 2023-10-16 |  | SI Test | PP | SIT | 5.0 | Simon Berry | Systems Integration Testing (SIT) | Complete | COMPLETE |  |  |  |  |
| 725 | 1.4.1.4.1.7.4.2 | Test Management Tool onboarding |  | 25d | 2023-10-16 A | 2023-11-17 A |  | 100% | 2023-10-16 | 2023-11-17 | 60d | 2023-07-17 | 2023-10-06 | start no earlier than 2023-10-16 |  | PP | SI Test | SIT | 5.0 | Simon Berry | Systems Integration Testing (SIT) | Complete | COMPLETE |  |  |  |  |
| 726 | 1.4.1.4.1.7.5 | **SIT Component Integration Test Readiness Report** |  | 25d | 2023-10-16 A | 2023-11-17 A |  | 100% | 2023-10-16 | 2023-11-17 | 25d | 2023-10-16 | 2023-11-17 |  |  | N/A | N/A | SIT | 5.0 | N/A | Systems Integration Testing (SIT) |  |  |  |  |  |  |
| 727 | 1.4.1.4.1.7.5.1 | PP submit Test Readiness Report to Programme for assurance | milestone | 0d | 2023-11-03 A | 2023-11-03 A | 611 | 100% | 2023-11-03 | 2023-11-03 | 0d | 2023-11-03 | 2023-11-03 |  |  | PP | SI Test | SIT | 5.0 |  | Systems Integration Testing (SIT) | Complete | COMPLETE |  |  |  |  |
| 728 | 1.4.1.4.1.7.5.2 | SI assure Test Participants' Test Readiness Reports |  | 5d | 2023-11-06 A | 2023-11-10 A | 727FF+5d | 100% | 2023-11-06 | 2023-11-10 | 5d | 2023-11-06 | 2023-11-10 |  |  | SI Test | PP,IPA | SIT | 5.0 |  | Systems Integration Testing (SIT) | Complete | COMPLETE |  |  |  |  |
| 729 | 1.4.1.4.1.7.5.3 | SI develop Overarching SIT Component Integration Test Readiness Report |  | 20d | 2023-10-16 A | 2023-11-10 A | 728FF | 100% | 2023-10-16 | 2023-11-10 | 20d | 2023-10-16 | 2023-11-10 |  |  | SI Test |  | SIT | 5.0 |  | Systems Integration Testing (SIT) | Complete | COMPLETE |  |  |  |  |
| 730 | 1.4.1.4.1.7.5.4 | Artefact review (via TMAG) and updates |  | 5d | 2023-11-13 A | 2023-11-17 A | 729 | 100% | 2023-11-13 | 2023-11-17 | 5d | 2023-11-13 | 2023-11-17 |  |  | SI Test | PP,IPA | SIT | 5.0 |  | Systems Integration Testing (SIT) | Complete | COMPLETE |  |  |  |  |
| 731 | 1.4.1.4.1.7.6 | SIT Component Integration Testing 3 Preparation Complete (incl. approval of SI SIT Component Integration Test Readiness Report) | milestone | 0d | 2023-11-20 A | 2023-11-20 A | 730FS+1d, 704, 708, 727, 725, 722, 321 | 100% | 2023-11-20 | 2023-11-20 | 0d | 2023-11-20 | 2023-11-20 |  |  | SI Test | PP,IPA | SIT | 5.12 |  | Systems Integration Testing (SIT) | Complete | COMPLETE | MHHS-ART071 | T2-TE-0350 | SITAG | T2 |
| 732 | 1.4.1.4.1.8 | **CIT Interval 4 Preparation** |  | 36d | 2023-10-16 A | 2023-12-04 A |  | 100% | 2023-10-16 | 2023-12-04 | 36d | 2022-11-16 | 2023-12-04 |  | -0 | N/A | N/A | SIT | 5.0 | N/A | Systems Integration Testing (SIT) |  |  |  |  |  |  |
| 733 | 1.4.1.4.1.8.1 | **PIT Test Completion Report (incl. evidence)** |  | 21d | 2023-10-27 A | 2023-11-24 A |  | 100% | 2023-10-27 | 2023-11-24 | 21d | 2023-10-27 | 2023-11-24 |  |  | N/A | N/A | SIT | 5.0 | N/A | Systems Integration Testing (SIT) |  |  |  |  |  |  |
| 734 | 1.4.1.4.1.8.1.1 | Submit draft PIT Test Completion Report (incl. evidence) and submit to Programme for assurance |  | 1d | 2023-10-27 A | 2023-10-27 A |  | 100% | 2023-10-27 | 2023-10-27 | 1d | 2023-10-27 | 2023-10-27 | must start on 2023-10-27 |  | PP | SI Test | SIT | 5.0 |  | Systems Integration Testing (SIT) | Complete | COMPLETE |  |  |  |  |
| 735 | 1.4.1.4.1.8.1.2 | Finalise PIT Test Completion Report (incl. evidence) |  | 15d | 2023-10-30 A | 2023-11-17 A | 734 | 100% | 2023-10-30 | 2023-11-17 | 15d | 2023-10-30 | 2023-11-17 |  |  | PP | SI Test | SIT | 5.0 |  | Systems Integration Testing (SIT) | Complete | COMPLETE |  |  |  |  |
| 736 | 1.4.1.4.1.8.1.3 | PP PIT Completion Report (excl. Migration/Reverse Migration) submitted to Programme for assurance CIT Interval 4 | milestone | 0d | 2023-11-17 A | 2023-11-17 A | 735, 79, 95 | 100% | 2023-11-17 | 2023-11-17 | 0d | 2023-11-17 | 2023-11-17 |  |  | PP | SI Test | SIT | 5.13 |  | Systems Integration Testing (SIT) | Complete | COMPLETE |  | T3-DB-0019 | SITAG | T3 |
| 737 | 1.4.1.4.1.8.1.4 | PP Final PIT Completion Reports assured by SI |  | 5d | 2023-11-20 A | 2023-11-24 A | 736 | 100% | 2023-11-20 | 2023-11-24 | 5d | 2023-11-20 | 2023-11-24 |  |  | SI Test | PP | SIT | 5.0 |  | Systems Integration Testing (SIT) | Complete | COMPLETE |  |  |  |  |
| 738 | 1.4.1.4.1.8.2 | **Environments (SIT A)** |  | 25d | 2023-10-23 A | 2023-11-24 A |  | 100% | 2023-10-23 | 2023-11-24 | 25d | 2022-11-16 | 2023-11-24 |  | -0 | N/A | N/A | SIT | 5.0 | N/A | Systems Integration Testing (SIT) |  |  |  |  |  |  |
| 739 | 1.4.1.4.1.8.2.1 | Programme Participants Ready to Start Connectivity Proving | milestone | 0d | 2023-10-23 A | 2023-10-23 A |  | 100% | 2023-10-23 | 2023-10-23 | 0d |  |  | start no earlier than 2023-10-23 |  | PP |  | SIT | 5.10 | Simon Berry | Systems Integration Testing (SIT) | Complete | COMPLETE |  |  |  |  |
| 740 | 1.4.1.4.1.8.2.2 | SIT Participants' SIT A environments ready to start connectivity proving CIT Interval 4 | milestone | 0d | 2023-10-23 A | 2023-10-23 A | 739 | 100% | 2023-10-23 | 2023-10-23 | 0d | 2023-10-20 | 2023-10-20 |  |  | PP | PP,IPA | SIT | 5.10 | Simon Berry | Systems Integration Testing (SIT) | Complete | COMPLETE | MHHS-ART139 | T3-TE-0022 | SITAG | T3 |
| 741 | 1.4.1.4.1.8.2.3 | Internal Connectivity Proving Phase |  | 10d | 2023-10-23 A | 2023-11-03 A | 740 | 100% | 2023-10-23 | 2023-11-03 | 10d |  |  |  |  | PP |  | SIT | 5.10 | Simon Berry | Systems Integration Testing (SIT) | Complete | COMPLETE |  |  |  |  |
| 742 | 1.4.1.4.1.8.2.4 | Internal Connectivity Proving Phase Complete | milestone | 0d | 2023-11-03 A | 2023-11-03 A | 741 | 100% | 2023-11-03 | 2023-11-03 | 0d |  |  |  |  | PP |  | SIT | 5.10 | Simon Berry | Systems Integration Testing (SIT) | Complete | COMPLETE |  |  |  |  |
| 743 | 1.4.1.4.1.8.2.5 | DIP Onboarding Activity (1. PKI Officers and Certificates, 2. Set-up Validation, 3. End Point Creation, 4. Controlled Smoke Test ) |  | 10d | 2023-11-13 A | 2023-11-24 A | 742FS+5d | 100% | 2023-11-13 | 2023-11-24 | 10d |  |  |  |  | PP |  | SIT | 5.10 | Simon Berry | Systems Integration Testing (SIT) | Complete | COMPLETE |  |  |  |  |
| 744 | 1.4.1.4.1.8.2.6 | DIP Onboarding Complete | milestone | 0d | 2023-11-24 A | 2023-11-24 A | 743 | 100% | 2023-11-24 | 2023-11-24 | 0d |  |  |  |  | PP |  | SIT | 5.10 | Simon Berry | Systems Integration Testing (SIT) | Complete | COMPLETE |  |  |  |  |
| 745 | 1.4.1.4.1.8.2.7 | PPs register PKI Officers and Request PKI Certificates Complete - Interval 4 | milestone | 0d | 2023-11-24 A | 2023-11-24 A | 744 | 100% | 2023-11-24 | 2023-11-24 | 0d |  |  |  |  | PP | DIP Provider | SIT | 5.16 | Simon Berry | Systems Integration Testing (SIT) | Complete | COMPLETE |  | T3-TE-0100 | SITAG | T3 |
| 746 | 1.4.1.4.1.8.2.8 | PP Code Deployment | milestone | 0d | 2023-11-17 A | 2023-11-17 A |  | 100% | 2023-11-17 | 2023-11-17 | 0d |  |  | start no earlier than 2023-11-17 |  | PP |  | SIT | 5.10 | Simon Berry | Systems Integration Testing (SIT) | Complete | COMPLETE |  |  |  |  |

Notes:
- 722: Action: 28/7: CH: Needs to be set-up as a reporting milestone. 31/7: Check with Cesar if has been approved so can be baselined

| ID | WBS | Task | Type | Duration | Start | Finish | Predecessors | Complete | Baseline start | Baseline finish | Baseline duration | Baseline 1 start | Baseline 1 finish | Constraint | Baseline cost | Responsible | Involved | Text9 | Update Version | MHHS Resource Name | MHHS Programme Phase | Sched Status | RAG | Artefact ID | Milestone ID | Text29 | Tier |
| --- | --- | --- | --- | --- | --- | --- | --- | --- | --- | --- | --- | --- | --- | --- | --- | --- | --- | --- | --- | --- | --- | --- | --- | --- | --- | --- | --- |
| 747 | 1.4.1.4.1.8.3 | **Test Data (SIT A) Interval 4** |  | 30d | 2023-10-23 A | 2023-12-01 A |  | 100% | 2023-10-23 | 2023-12-01 | 25d | 2023-10-16 | 2023-11-17 |  |  | N/A | N/A | SIT | 5.0 | N/A | Systems Integration Testing (SIT) |  |  |  |  |  |  |
| 748 | 1.4.1.4.1.8.3.1 | Run data allocation |  | 5d | 2023-10-23 A | 2023-10-27 A | 717FS+5d | 100% | 2023-10-23 | 2023-10-27 | 5d | 2023-10-16 | 2023-10-20 |  |  | SI Test |  | SIT | 5.0 | Cesar Lopes | Systems Integration Testing (SIT) | Complete | COMPLETE |  |  |  |  |
| 749 | 1.4.1.4.1.8.3.2 | Cleanse and populate data post cut |  | 2d | 2023-10-30 A | 2023-10-31 A | 748 | 100% | 2023-10-30 | 2023-10-31 | 5d | 2023-10-23 | 2023-10-27 |  |  | SI Test |  | SIT | 5.0 | Cesar Lopes | Systems Integration Testing (SIT) | Complete | COMPLETE |  |  |  |  |
| 750 | 1.4.1.4.1.8.3.3 | Transmit data sets to PPs |  | 5d | 2023-11-01 A | 2023-11-07 A | 749 | 100% | 2023-11-01 | 2023-11-07 | 2d | 2023-10-30 | 2023-10-31 |  |  | SI Test |  | SIT | 5.0 | Cesar Lopes | Systems Integration Testing (SIT) | Complete | COMPLETE |  |  |  |  |
| 751 | 1.4.1.4.1.8.3.4 | PP - Load test data to test environments |  | 5d | 2023-11-08 A | 2023-11-14 A | 750 | 100% | 2023-11-08 | 2023-11-14 | 8d | 2023-11-01 | 2023-11-10 |  |  | PP |  | SIT | 5.0 | Cesar Lopes | Systems Integration Testing (SIT) | Complete | COMPLETE |  |  |  |  |
| 752 | 1.4.1.4.1.8.3.5 | PP Check data integrity on test environment |  | 13d | 2023-11-15 A | 2023-12-01 A | 751 | 100% | 2023-11-15 | 2023-12-01 | 5d | 2023-11-13 | 2023-11-17 |  |  | PP |  | SIT | 5.0 | Richard Puddephatt | Systems Integration Testing (SIT) | Complete | COMPLETE |  |  |  |  |
| 753 | 1.4.1.4.1.8.3.6 | PP submit self-declaration to Programme to confirm loading & verification of test data | milestone | 0d | 2023-12-01 A | 2023-12-01 A | 752FF | 100% | 2023-12-01 | 2023-12-01 | 0d | 2023-11-17 | 2023-11-17 |  |  | PP | SI Test | SIT | 5.0 | Richard Puddephatt | Systems Integration Testing (SIT) | Complete | COMPLETE |  |  |  |  |
| 754 | 1.4.1.4.1.8.3.7 | Test Data (SIT A) Interval 4 Complete | milestone | 0d | 2023-12-01 A | 2023-12-01 A | 753 | 100% | 2023-12-01 | 2023-12-01 | 0d |  |  |  |  | SI Test | PP | SIT | 5.13 | Richard Puddephatt | Systems Integration Testing (SIT) | Complete | COMPLETE | MHHS-ART148/169 | T3-TE-0076 | SITAG | T3 |
| 755 | 1.4.1.4.1.8.4 | **Other Preparation** |  | 25d | 2023-10-30 A | 2023-12-01 A |  | 100% | 2023-10-30 | 2023-12-01 | 25d | 2023-07-31 | 2023-10-20 |  | -0 | N/A | N/A | SIT | 5.0 | N/A | Systems Integration Testing (SIT) |  |  |  |  |  |  |
| 756 | 1.4.1.4.1.8.4.1 | Onboarding of Test Participants to Test Management Tool (Azure DevOps) |  | 25d | 2023-10-30 A | 2023-12-01 A |  | 100% | 2023-10-30 | 2023-12-01 | 25d | 2023-07-31 | 2023-10-20 | start no earlier than 2023-10-30 |  | SI Test | PP | SIT | 5.0 | Simon Berry | Systems Integration Testing (SIT) | Complete | COMPLETE |  |  |  |  |
| 757 | 1.4.1.4.1.8.4.2 | Test Management Tool onboarding |  | 25d | 2023-10-30 A | 2023-12-01 A |  | 100% | 2023-10-30 | 2023-12-01 | 25d | 2023-07-31 | 2023-10-20 | start no earlier than 2023-10-30 |  | PP | SI Test | SIT | 5.0 | Simon Berry | Systems Integration Testing (SIT) | Complete | COMPLETE |  |  |  |  |
| 758 | 1.4.1.4.1.8.5 | **SIT Component Integration Test Readiness Report** |  | 27d | 2023-10-16 A | 2023-11-21 A |  | 100% | 2023-10-16 | 2023-11-21 | 25d | 2023-10-30 | 2023-12-01 |  |  | N/A | N/A | SIT | 5.0 | N/A | Systems Integration Testing (SIT) |  |  |  |  |  |  |
| 759 | 1.4.1.4.1.8.5.1 | PP submit Test Readiness Report to Programme for assurance | milestone | 0d | 2023-11-03 A | 2023-11-03 A | 611 | 100% | 2023-11-03 | 2023-11-03 | 0d | 2023-11-17 | 2023-11-17 |  |  | PP | SI Test | SIT | 5.0 |  | Systems Integration Testing (SIT) | Complete | COMPLETE |  |  |  |  |
| 760 | 1.4.1.4.1.8.5.2 | SI assure Test Participants' Test Readiness Reports |  | 5d | 2023-11-06 A | 2023-11-10 A | 759FF+5d | 100% | 2023-11-06 | 2023-11-10 | 5d | 2023-11-20 | 2023-11-24 |  |  | SI Test | PP,IPA | SIT | 5.0 |  | Systems Integration Testing (SIT) | Complete | COMPLETE |  |  |  |  |
| 761 | 1.4.1.4.1.8.5.3 | SI develop Overarching SIT Component Integration Test Readiness Report |  | 20d | 2023-10-16 A | 2023-11-10 A | 760FF | 100% | 2023-10-16 | 2023-11-10 | 20d | 2023-10-30 | 2023-11-24 |  |  | SI Test |  | SIT | 5.0 |  | Systems Integration Testing (SIT) | Complete | COMPLETE |  |  |  |  |
| 762 | 1.4.1.4.1.8.5.4 | Artefact review (via SITAG) and updates |  | 7d | 2023-11-13 A | 2023-11-21 A | 761 | 100% | 2023-11-13 | 2023-11-21 | 5d | 2023-11-27 | 2023-12-01 |  |  | SI Test | PP,IPA | SIT | 5.0 |  | Systems Integration Testing (SIT) | Complete | COMPLETE |  |  |  |  |
| 763 | 1.4.1.4.1.8.6 | SIT Component Integration Testing 4 Preparation Complete (incl. approval of SI SIT Component Integration Test Readiness Report) | milestone | 0d | 2023-12-04 A | 2023-12-04 A | 762FS+2d, 736, 740, 759, 754, 338FS+1d | 100% | 2023-12-04 | 2023-12-04 | 0d | 2023-12-04 | 2023-12-04 |  |  | SI Test | PP,IPA | SIT | 5.13 |  | Systems Integration Testing (SIT) | Complete | COMPLETE | MHHS-ART071 | T2-TE-0400 | SITAG | T2 |
| 764 | 1.4.1.4.1.9 | **CIT Interval 5 Preparation** |  | 53d | 2023-11-01 A | 2024-01-12 A |  | 100% | 2023-11-01 | 2024-01-12 | 55d | 2022-11-16 | 2024-01-08 |  | -0 | N/A | N/A | SIT | 5.0 | N/A | Systems Integration Testing (SIT) |  |  |  |  |  |  |
| 765 | 1.4.1.4.1.9.1 | **PIT Test Completion Report (incl. evidence)** |  | 21d | 2023-11-17 A | 2023-12-15 A |  | 100% | 2023-11-17 | 2023-12-15 | 21d | 2023-11-17 | 2023-12-15 |  |  | N/A | N/A | SIT | 5.0 | N/A | Systems Integration Testing (SIT) |  |  |  |  |  |  |
| 766 | 1.4.1.4.1.9.1.1 | Submit draft PIT Test Completion Report (incl. evidence) and submit to Programme for assurance |  | 1d | 2023-11-17 A | 2023-11-17 A |  | 100% | 2023-11-17 | 2023-11-17 | 1d | 2023-11-17 | 2023-11-17 | must start on 2023-11-17 |  | PP | SI Test | SIT | 5.0 | Lee Cox | Systems Integration Testing (SIT) | Complete | COMPLETE |  |  |  |  |
| 767 | 1.4.1.4.1.9.1.2 | Finalise PIT Test Completion Report (incl. evidence) |  | 15d | 2023-11-20 A | 2023-12-08 A | 766 | 100% | 2023-11-20 | 2023-12-08 | 15d | 2023-11-20 | 2023-12-08 |  |  | PP | SI Test | SIT | 5.0 | Lee Cox | Systems Integration Testing (SIT) | Complete | COMPLETE |  |  |  |  |
| 768 | 1.4.1.4.1.9.1.3 | PP PIT Completion Report (excl. Migration/Reverse Migration) submitted to Programme for assurance CIT Interval 5 | milestone | 0d | 2023-12-08 A | 2023-12-08 A | 767, 79, 95 | 100% | 2023-12-08 | 2023-12-08 | 0d | 2023-12-08 | 2023-12-08 |  |  | PP | SI Test | SIT | 5.14 | Lee Cox | Systems Integration Testing (SIT) | Complete | COMPLETE |  | T3-DB-0021 | SITAG | T3 |
| 769 | 1.4.1.4.1.9.1.4 | PP Final PIT Completion Reports assured by SI |  | 5d | 2023-12-11 A | 2023-12-15 A | 768 | 100% | 2023-12-11 | 2023-12-15 | 5d | 2023-12-11 | 2023-12-15 |  |  | SI Test | PP | SIT | 5.0 | Lee Cox | Systems Integration Testing (SIT) | Complete | COMPLETE |  |  |  |  |
| 770 | 1.4.1.4.1.9.2 | **Environments (SIT A)** |  | 21d | 2023-11-10 A | 2023-12-08 A |  | 100% | 2023-11-10 | 2023-12-08 | 21d | 2022-11-16 | 2023-12-15 |  | -0 | N/A | N/A | SIT | 5.0 | N/A | Systems Integration Testing (SIT) |  |  |  |  |  |  |
| 771 | 1.4.1.4.1.9.2.1 | Programme Participants Ready to Start Connectivity Proving | milestone | 0d | 2023-11-10 A | 2023-11-10 A |  | 100% | 2023-11-10 | 2023-11-10 | 0d |  |  | start no earlier than 2023-11-10 |  | PP |  | SIT | 5.10 | Simon Berry | Systems Integration Testing (SIT) | Complete | COMPLETE |  |  |  |  |
| 772 | 1.4.1.4.1.9.2.2 | SIT Participants' SIT A environments ready to start connectivity proving CIT Interval 5 | milestone | 0d | 2023-11-10 A | 2023-11-10 A | 771 | 100% | 2023-11-10 | 2023-11-10 | 0d | 2023-11-10 | 2023-11-10 |  |  | PP | PP,IPA | SIT | 5.6 | Simon Berry | Systems Integration Testing (SIT) | Complete | COMPLETE | MHHS-ART139 | T3-TE-0023 | SITAG | T3 |
| 773 | 1.4.1.4.1.9.2.3 | Internal Connectivity Proving Phase |  | 10d | 2023-11-13 A | 2023-11-24 A | 771FS+1d | 100% | 2023-11-13 | 2023-11-24 | 10d |  |  |  |  | PP |  | SIT | 5.10 | Simon Berry | Systems Integration Testing (SIT) | Complete | COMPLETE |  |  |  |  |
| 774 | 1.4.1.4.1.9.2.4 | Internal Connectivity Proving Phase Complete | milestone | 0d | 2023-11-24 A | 2023-11-24 A | 773 | 100% | 2023-11-24 | 2023-11-24 | 0d |  |  |  |  | PP |  | SIT | 5.10 | Simon Berry | Systems Integration Testing (SIT) | Complete | COMPLETE |  |  |  |  |
| 775 | 1.4.1.4.1.9.2.5 | DIP Onboarding Activity (1. PKI Officers and Certificates, 2. Set-up Validation, 3. End Point Creation, 4. Controlled Smoke Test ) |  | 10d | 2023-11-27 A | 2023-12-08 A | 774 | 100% | 2023-11-27 | 2023-12-08 | 10d |  |  |  |  | PP |  | SIT | 5.10 | Simon Berry | Systems Integration Testing (SIT) | Complete | COMPLETE |  |  |  |  |
| 776 | 1.4.1.4.1.9.2.6 | DIP Onboarding Complete | milestone | 0d | 2023-12-08 A | 2023-12-08 A | 775 | 100% | 2023-12-08 | 2023-12-08 | 0d |  |  |  |  | PP |  | SIT | 5.10 | Simon Berry | Systems Integration Testing (SIT) | Complete | COMPLETE |  |  |  |  |
| 777 | 1.4.1.4.1.9.2.7 | PPs register PKI Officers and Request PKI Certificates Complete - Interval 5 | milestone | 0d | 2023-12-08 A | 2023-12-08 A | 776 | 100% | 2023-12-08 | 2023-12-08 | 0d | 2023-11-06 | 2023-11-10 |  |  | PP | DIP Provider | SIT | 5.17 | Simon Berry | Systems Integration Testing (SIT) | Complete | COMPLETE |  | T3-TE-0101 | SITAG | T3 |
| 778 | 1.4.1.4.1.9.2.8 | PP Code Deployment | milestone | 0d | 2023-12-08 A | 2023-12-08 A | 777 | 100% | 2023-12-08 | 2023-12-08 | 0d |  |  | start no earlier than 2023-10-20 |  | PP |  | SIT | 5.10 | Simon Berry | Systems Integration Testing (SIT) | Complete | COMPLETE |  |  |  |  |

| ID | WBS | Task | Type | Duration | Start | Finish | Predecessors | Complete | Baseline start | Baseline finish | Baseline duration | Baseline 1 start | Baseline 1 finish | Constraint | Baseline cost | Responsible | Involved | Text9 | Update Version | MHHS Resource Name | MHHS Programme Phase | Sched Status | RAG | Artefact ID | Milestone ID | Text29 | Tier |
| --- | --- | --- | --- | --- | --- | --- | --- | --- | --- | --- | --- | --- | --- | --- | --- | --- | --- | --- | --- | --- | --- | --- | --- | --- | --- | --- | --- |
| 779 | 1.4.1.4.1.9.3 | **Test Data (SIT A) Interval 5** |  | 33d | 2023-11-01 A | 2023-12-15 A |  | 100% | 2023-11-01 | 2023-12-15 | 30d | 2023-10-30 | 2023-12-08 |  |  | N/A | N/A | SIT | 5.0 | N/A | Systems Integration Testing (SIT) |  |  |  |  |  |  |
| 780 | 1.4.1.4.1.9.3.1 | Run data allocation |  | 5d | 2023-11-01 A | 2023-11-07 A | 750SS | 100% | 2023-11-01 | 2023-11-07 | 10d | 2023-10-30 | 2023-11-10 |  |  | SI Test |  | SIT | 5.0 | Cesar Lopes | Systems Integration Testing (SIT) | Complete | COMPLETE |  |  |  |  |
| 781 | 1.4.1.4.1.9.3.2 | Cleanse and populate data post cut |  | 8d | 2023-11-08 A | 2023-11-17 A | 780 | 100% | 2023-11-08 | 2023-11-17 | 5d | 2023-11-13 | 2023-11-17 |  |  | SI Test |  | SIT | 5.0 | Cesar Lopes | Systems Integration Testing (SIT) | Complete | COMPLETE |  |  |  |  |
| 782 | 1.4.1.4.1.9.3.3 | Transmit data sets to PPs |  | 2d | 2023-11-20 A | 2023-11-21 A | 781 | 100% | 2023-11-20 | 2023-11-21 | 2d | 2023-11-20 | 2023-11-21 |  |  | SI Test |  | SIT | 5.0 | Cesar Lopes | Systems Integration Testing (SIT) | Complete | COMPLETE |  |  |  |  |
| 783 | 1.4.1.4.1.9.3.4 | PP - Load test data to test environments |  | 8d | 2023-11-22 A | 2023-12-01 A | 782 | 100% | 2023-11-22 | 2023-12-01 | 8d | 2023-11-22 | 2023-12-01 |  |  | PP |  | SIT | 5.0 | Richard Puddephatt | Systems Integration Testing (SIT) | Complete | COMPLETE |  |  |  |  |
| 784 | 1.4.1.4.1.9.3.5 | PP Check data integrity on test environment |  | 10d | 2023-12-04 A | 2023-12-15 A | 783 | 100% | 2023-12-04 | 2023-12-15 | 5d | 2023-12-04 | 2023-12-08 |  |  | PP |  | SIT | 5.0 | Richard Puddephatt | Systems Integration Testing (SIT) | Complete | COMPLETE |  |  |  |  |
| 785 | 1.4.1.4.1.9.3.6 | PP submit self-declaration to Programme to confirm loading & verification of test data | milestone | 0d | 2023-12-15 A | 2023-12-15 A | 784FF | 100% | 2023-12-15 | 2023-12-15 | 0d | 2023-12-08 | 2023-12-08 |  |  | PP | SI Test | SIT | 5.0 | Richard Puddephatt | Systems Integration Testing (SIT) | Complete | COMPLETE |  |  |  |  |
| 786 | 1.4.1.4.1.9.3.7 | Test Data (SIT A) Interval 5 Complete | milestone | 0d | 2023-12-15 A | 2023-12-15 A | 785 | 100% | 2023-12-15 | 2023-12-15 | 0d |  |  |  |  | SI Test | PP | SIT | 5.14 | Richard Puddephatt | Systems Integration Testing (SIT) | Complete | COMPLETE | MHHS-ART148/169 | T3-TE-0077 | SITAG | T3 |
| 787 | 1.4.1.4.1.9.4 | **Other Preparation** |  | 40d | 2023-11-20 A | 2024-01-12 A |  | 100% | 2023-11-20 | 2024-01-12 | 40d | 2023-08-21 | 2023-11-10 |  | -0 | N/A | N/A | SIT | 5.0 | N/A | Systems Integration Testing (SIT) |  |  |  |  |  |  |
| 788 | 1.4.1.4.1.9.4.1 | Onboarding of Test Participants to Test Management Tool (Azure DevOps) |  | 40d | 2023-11-20 A | 2024-01-12 A |  | 100% | 2023-11-20 | 2024-01-12 | 40d | 2023-08-21 | 2023-11-10 | start no earlier than 2023-11-20 |  | SI Test | PP | SIT | 5.0 | Simon Berry | Systems Integration Testing (SIT) | Complete | COMPLETE |  |  |  |  |
| 789 | 1.4.1.4.1.9.4.2 | Test Management Tool onboarding |  | 36d | 2023-11-20 A | 2024-01-08 A |  | 100% | 2023-11-20 | 2024-01-08 | 36d | 2023-08-21 | 2023-11-10 | start no earlier than 2023-11-20 |  | PP | SI Test | SIT | 5.0 | Simon Berry | Systems Integration Testing (SIT) | Complete | COMPLETE |  |  |  |  |
| 790 | 1.4.1.4.1.9.5 | **SIT Component Integration Test Readiness Report** |  | 35d | 2023-11-20 A | 2024-01-05 A |  | 100% | 2023-11-20 | 2024-01-05 | 35d | 2023-11-20 | 2024-01-05 |  |  | N/A | N/A | SIT | 5.0 | N/A | Systems Integration Testing (SIT) |  |  |  |  |  |  |
| 791 | 1.4.1.4.1.9.5.1 | PP submit Test Readiness Report to Programme for assurance | milestone | 0d | 2023-12-08 A | 2023-12-08 A | 615 | 100% | 2023-12-08 | 2023-12-08 | 0d | 2023-12-08 | 2023-12-08 |  |  | PP | SI Test | SIT | 5.0 | Lee Cox | Systems Integration Testing (SIT) | Complete | COMPLETE |  |  |  |  |
| 792 | 1.4.1.4.1.9.5.2 | SI assure Test Participants' Test Readiness Reports |  | 5d | 2023-12-11 A | 2023-12-15 A | 791FF+5d | 100% | 2023-12-11 | 2023-12-15 | 5d | 2023-12-11 | 2023-12-15 |  |  | SI Test | PP,IPA | SIT | 5.0 | Lee Cox | Systems Integration Testing (SIT) | Complete | COMPLETE |  |  |  |  |
| 793 | 1.4.1.4.1.9.5.3 | SI develop Overarching SIT Component Integration Test Readiness Report |  | 20d | 2023-11-20 A | 2023-12-15 A | 792FF | 100% | 2023-11-20 | 2023-12-15 | 20d | 2023-11-20 | 2023-12-15 |  |  | SI Test |  | SIT | 5.0 | Lee Cox | Systems Integration Testing (SIT) | Complete | COMPLETE |  |  |  |  |
| 794 | 1.4.1.4.1.9.5.4 | Artefact review (via SITAG) and updates |  | 15d | 2023-12-18 A | 2024-01-05 A | 793 | 100% | 2023-12-18 | 2024-01-05 | 15d | 2023-12-18 | 2024-01-05 |  |  | SI Test | PP,IPA | SIT | 5.0 | Lee Cox | Systems Integration Testing (SIT) | Complete | COMPLETE |  |  |  |  |
| 795 | 1.4.1.4.1.9.6 | SIT Component Integration Testing 5 Preparation Complete (incl. approval of SI SIT Component Integration Test Readiness Report) | milestone | 0d | 2024-01-08 A | 2024-01-08 A | 794FS+1d, 768, 772, 789, 791, 786, 441, 424 | 100% | 2024-01-08 | 2024-01-08 | 0d | 2024-01-08 | 2024-01-08 |  |  | SI Test | PP,IPA | SIT | 5.15 |  | Systems Integration Testing (SIT) | Complete | COMPLETE | MHHS-ART071 | T2-TE-0450 | SITAG | T2 |
| 796 | 1.4.1.4.1.10 | **CIT Interval 6 Preparation** |  | 45d | 2023-11-20 A | 2024-01-19 A |  | 100% | 2023-11-20 | 2024-01-19 | 46d | 2022-11-16 | 2024-01-22 |  | -0 | N/A | N/A | SIT | 5.0 | N/A | Systems Integration Testing (SIT) |  |  |  |  |  |  |
| 797 | 1.4.1.4.1.10.1 | **PIT Test Completion Report (incl. evidence)** |  | 31d | 2023-12-01 A | 2024-01-12 A |  | 100% | 2023-12-01 | 2024-01-12 | 31d | 2023-12-01 | 2024-01-12 |  |  | N/A | N/A | SIT | 5.0 | N/A | Systems Integration Testing (SIT) |  |  |  |  |  |  |
| 798 | 1.4.1.4.1.10.1.1 | Submit draft PIT Test Completion Report (incl. evidence) and submit to Programme for assurance |  | 1d | 2023-12-01 A | 2023-12-01 A |  | 100% | 2023-12-01 | 2023-12-01 | 1d | 2023-12-01 | 2023-12-01 | must start on 2023-12-01 |  | PP | SI Test | SIT | 5.0 |  | Systems Integration Testing (SIT) | Complete | COMPLETE |  |  |  |  |
| 799 | 1.4.1.4.1.10.1.2 | Finalise PIT Test Completion Report (incl. evidence) |  | 25d | 2023-12-04 A | 2024-01-05 A | 798 | 100% | 2023-12-04 | 2024-01-05 | 25d | 2023-12-04 | 2024-01-05 |  |  | PP | SI Test | SIT | 5.0 |  | Systems Integration Testing (SIT) | Complete | COMPLETE |  |  |  |  |
| 800 | 1.4.1.4.1.10.1.3 | PP PIT Completion Report (excl. Migration/Reverse Migration) submitted to Programme for assurance CIT Interval 6 | milestone | 0d | 2024-01-05 A | 2024-01-05 A | 799, 79, 95, 260, 265, 268 | 100% | 2024-01-05 | 2024-01-05 | 0d | 2024-01-05 | 2024-01-05 |  |  | PP | SI Test | SIT | 5.19 |  | Systems Integration Testing (SIT) | Complete | COMPLETE |  | T3-DB-0023 | SITAG | T3 |
| 801 | 1.4.1.4.1.10.1.4 | PP Final PIT Completion Reports assured by SI |  | 5d | 2024-01-08 A | 2024-01-12 A | 800 | 100% | 2024-01-08 | 2024-01-12 | 5d | 2024-01-08 | 2024-01-12 |  |  | SI Test | PP | SIT | 5.19 |  | Systems Integration Testing (SIT) | Complete | COMPLETE |  |  |  |  |
| 802 | 1.4.1.4.1.10.2 | **Environments (SIT A)** |  | 30d | 2023-11-24 A | 2024-01-05 A |  | 100% | 2023-11-24 | 2024-01-05 | 30d | 2022-11-16 | 2024-01-05 |  | -0 | N/A | N/A | SIT | 5.0 | N/A | Systems Integration Testing (SIT) |  |  |  |  |  |  |
| 803 | 1.4.1.4.1.10.2.1 | Programme Participants Ready to Start Connectivity Proving | milestone | 0d | 2023-11-24 A | 2023-11-24 A |  | 100% | 2023-11-24 | 2023-11-24 | 0d |  |  | start no earlier than 2023-11-24 |  | PP |  | SIT | 5.10 | Simon Berry | Systems Integration Testing (SIT) | Complete | COMPLETE |  |  |  |  |
| 804 | 1.4.1.4.1.10.2.2 | SIT Participants' SIT A environments ready to start connectivity proving CIT Interval 6 | milestone | 0d | 2023-11-24 A | 2023-11-24 A | 803 | 100% | 2023-11-24 | 2023-11-24 | 0d | 2023-11-24 | 2023-11-24 |  |  | PP | PP,IPA | SIT | 5.6 | Simon Berry | Systems Integration Testing (SIT) | Complete | COMPLETE | MHHS-ART139 | T3-TE-0024 | SITAG | T3 |
| 805 | 1.4.1.4.1.10.2.3 | Internal Connectivity Proving Phase |  | 10d | 2023-11-27 A | 2023-12-08 A | 804FS+1d | 100% | 2023-11-27 | 2023-12-08 | 10d |  |  |  |  | PP |  | SIT | 5.10 | Simon Berry | Systems Integration Testing (SIT) | Complete | COMPLETE |  |  |  |  |
| 806 | 1.4.1.4.1.10.2.4 | Internal Connectivity Proving Phase Complete | milestone | 0d | 2023-12-08 A | 2023-12-08 A | 805 | 100% | 2023-12-08 | 2023-12-08 | 0d |  |  |  |  | PP |  | SIT | 5.10 | Simon Berry | Systems Integration Testing (SIT) | Complete | COMPLETE |  |  |  |  |
| 807 | 1.4.1.4.1.10.2.5 | DIP Onboarding Activity (1. PKI Officers and Certificates, 2. Set-up Validation, 3. End Point Creation, 4. Controlled Smoke Test ) |  | 5d | 2023-12-04 A | 2023-12-08 A | 804FS+6d | 100% | 2023-12-04 | 2023-12-08 | 5d |  |  |  |  | PP |  | SIT | 5.10 | Simon Berry | Systems Integration Testing (SIT) | Complete | COMPLETE |  |  |  |  |
| 808 | 1.4.1.4.1.10.2.6 | DIP Onboarding Complete | milestone | 0d | 2023-12-08 A | 2023-12-08 A | 807 | 100% | 2023-12-08 | 2023-12-08 | 0d |  |  |  |  | PP |  | SIT | 5.10 | Simon Berry | Systems Integration Testing (SIT) | Complete | COMPLETE |  |  |  |  |
| 809 | 1.4.1.4.1.10.2.7 | PPs register PKI Officers and Request PKI Certificates Complete - Interval 6 | milestone | 0d | 2023-12-08 A | 2023-12-08 A | 808 | 100% | 2023-12-08 | 2023-12-08 | 0d | 2023-11-20 | 2023-11-24 | start no earlier than 2023-12-08 |  | PP | DIP Provider | SIT | 5.17 | Simon Berry | Systems Integration Testing (SIT) | Complete | COMPLETE |  | T3-TE-0102 | SITAG | T3 |
| 810 | 1.4.1.4.1.10.2.8 | PP Code Deployment | milestone | 0d | 2024-01-05 A | 2024-01-05 A |  | 100% | 2024-01-05 | 2024-01-05 | 0d |  |  | start no earlier than 2024-01-05 |  | PP |  | SIT | 5.10 | Simon Berry | Systems Integration Testing (SIT) | Complete | COMPLETE |  |  |  |  |

Notes:
- 786: Action: 28/7: CH: Needs to be set-up as a reporting milestone. 31/7: Check with Cesar if has been approved so can be baselined

| ID | WBS | Task | Type | Duration | Start | Finish | Predecessors | Complete | Remaining | Baseline start | Baseline finish | Baseline duration | Baseline 1 start | Baseline 1 finish | Total slack | Constraint | Baseline cost | Responsible | Involved | Text9 | Update Version | MHHS Resource Name | MHHS Programme Phase | Sched Status | RAG | Artefact ID | Milestone ID | Text29 | Tier |
| --- | --- | --- | --- | --- | --- | --- | --- | --- | --- | --- | --- | --- | --- | --- | --- | --- | --- | --- | --- | --- | --- | --- | --- | --- | --- | --- | --- | --- | --- |
| 811 | 1.4.1.4.1.10.3 | **Test Data (SIT A) Interval 6** |  | 25d | 2023-11-20 A | 2023-12-22 A |  | 100% |  | 2023-11-20 | 2023-12-22 | 25d | 2023-11-20 | 2023-12-22 |  |  |  | N/A | N/A | SIT | 5.0 | N/A | Systems Integration Testing (SIT) |  |  |  |  |  |  |
| 812 | 1.4.1.4.1.10.3.1 | Run data allocation |  | 10d | 2023-11-20 A | 2023-12-01 A | 782SS | 100% |  | 2023-11-20 | 2023-12-01 | 5d | 2023-11-20 | 2023-11-24 |  |  |  | SI Test |  | SIT | 5.0 | Richard Puddephatt | Systems Integration Testing (SIT) | Complete | COMPLETE |  |  |  |  |
| 813 | 1.4.1.4.1.10.3.2 | Cleanse and populate data post cut |  | 1d | 2023-12-04 A | 2023-12-04 A | 812 | 100% |  | 2023-12-04 | 2023-12-04 | 5d | 2023-11-27 | 2023-12-01 |  |  |  | SI Test |  | SIT | 5.0 | Richard Puddephatt | Systems Integration Testing (SIT) | Complete | COMPLETE |  |  |  |  |
| 814 | 1.4.1.4.1.10.3.3 | Transmit data sets to PPs |  | 1d | 2023-12-05 A | 2023-12-05 A | 813 | 100% |  | 2023-12-05 | 2023-12-05 | 2d | 2023-12-04 | 2023-12-05 |  |  |  | SI Test |  | SIT | 5.0 | Richard Puddephatt | Systems Integration Testing (SIT) | Complete | COMPLETE |  |  |  |  |
| 815 | 1.4.1.4.1.10.3.4 | PP - Load test data to test environments |  | 8d | 2023-12-06 A | 2023-12-15 A | 814 | 100% |  | 2023-12-06 | 2023-12-15 | 8d | 2023-12-06 | 2023-12-15 |  |  |  | PP |  | SIT | 5.0 | Richard Puddephatt | Systems Integration Testing (SIT) | Complete | COMPLETE |  |  |  |  |
| 816 | 1.4.1.4.1.10.3.5 | PP Check data integrity on test environment |  | 5d | 2023-12-18 A | 2023-12-22 A | 815 | 100% |  | 2023-12-18 | 2023-12-22 | 5d | 2023-12-18 | 2023-12-22 |  |  |  | PP |  | SIT | 5.0 | Richard Puddephatt | Systems Integration Testing (SIT) | Complete | COMPLETE |  |  |  |  |
| 817 | 1.4.1.4.1.10.3.6 | PP submit self-declaration to Programme to confirm loading & verification of test data | milestone | 0d | 2023-12-22 A | 2023-12-22 A | 816FF | 100% |  | 2023-12-22 | 2023-12-22 | 0d | 2023-12-22 | 2023-12-22 |  |  |  | PP | SI Test | SIT | 5.0 | Richard Puddephatt | Systems Integration Testing (SIT) | Complete | COMPLETE |  |  |  |  |
| 818 | 1.4.1.4.1.10.3.7 | Test Data (SIT A) Interval 6 Complete | milestone | 0d | 2023-12-22 A | 2023-12-22 A | 817 | 100% |  | 2023-12-22 | 2023-12-22 | 0d |  |  |  |  |  | SI Test | PP | SIT | 5.5 | Richard Puddephatt | Systems Integration Testing (SIT) | Complete | COMPLETE | MHHS-ART148/169 | T3-TE-0078 | SITAG | T3 |
| 819 | 1.4.1.4.1.10.4 | **Other Preparation** |  | 31d | 2023-12-04 A | 2024-01-15 A |  | 100% |  | 2023-12-04 | 2024-01-15 | 31d | 2023-09-04 | 2023-11-24 |  |  | -0 | N/A | N/A | SIT | 5.0 | N/A | Systems Integration Testing (SIT) |  |  |  |  |  |  |
| 820 | 1.4.1.4.1.10.4.1 | Onboarding of Test Participants to Test Management Tool (Azure DevOps) |  | 31d | 2023-12-04 A | 2024-01-15 A |  | 100% |  | 2023-12-04 | 2024-01-15 | 31d | 2023-09-04 | 2023-11-24 |  | start no earlier than 2023-12-04 |  | SI Test | PP | SIT | 5.0 | Simon Berry | Systems Integration Testing (SIT) | Complete | COMPLETE |  |  |  |  |
| 821 | 1.4.1.4.1.10.4.2 | Test Management Tool onboarding |  | 31d | 2023-12-04 A | 2024-01-15 A |  | 100% |  | 2023-12-04 | 2024-01-15 | 31d | 2023-09-04 | 2023-11-24 |  | start no earlier than 2023-12-04 |  | PP | SI Test | SIT | 5.0 | Simon Berry | Systems Integration Testing (SIT) | Complete | COMPLETE |  |  |  |  |
| 822 | 1.4.1.4.1.10.5 | **SIT Component Integration Test Readiness Report** |  | 25d | 2023-11-20 A | 2023-12-22 A |  | 100% |  | 2023-11-20 | 2023-12-22 | 25d | 2023-12-18 | 2024-01-19 |  |  |  | N/A | N/A | SIT | 5.0 | N/A | Systems Integration Testing (SIT) |  |  |  |  |  |  |
| 823 | 1.4.1.4.1.10.5.1 | PP submit Test Readiness Report to Programme for assurance | milestone | 0d | 2023-12-08 A | 2023-12-08 A | 615 | 100% |  | 2023-12-08 | 2023-12-08 | 0d | 2024-01-05 | 2024-01-05 |  |  |  | PP | SI Test | SIT | 5.0 |  | Systems Integration Testing (SIT) | Complete | COMPLETE |  |  |  |  |
| 824 | 1.4.1.4.1.10.5.2 | SI assure Test Participants' Test Readiness Reports |  | 5d | 2023-12-11 A | 2023-12-15 A | 823FF+5d | 100% |  | 2023-12-11 | 2023-12-15 | 5d | 2024-01-08 | 2024-01-12 |  |  |  | SI Test | PP,IPA | SIT | 5.0 |  | Systems Integration Testing (SIT) | Complete | COMPLETE |  |  |  |  |
| 825 | 1.4.1.4.1.10.5.3 | SI develop Overarching SIT Component Integration Test Readiness Report |  | 20d | 2023-11-20 A | 2023-12-15 A | 824FF | 100% |  | 2023-11-20 | 2023-12-15 | 20d | 2023-12-18 | 2024-01-12 |  |  |  | SI Test |  | SIT | 5.0 |  | Systems Integration Testing (SIT) | Complete | COMPLETE |  |  |  |  |
| 826 | 1.4.1.4.1.10.5.4 | Artefact review (via TMAG) and updates |  | 5d | 2023-12-18 A | 2023-12-22 A | 825 | 100% |  | 2023-12-18 | 2023-12-22 | 5d | 2024-01-15 | 2024-01-19 |  |  |  | SI Test | PP,IPA | SIT | 5.0 |  | Systems Integration Testing (SIT) | Complete | COMPLETE |  |  |  |  |
| 827 | 1.4.1.4.1.10.6 | SIT Component Integration Testing 6 Preparation Complete (incl. approval of SI SIT Component Integration Test Readiness Report) | milestone | 0d | 2024-01-19 A | 2024-01-19 A | 826FS+1d, 800, 804, 821, 823, 818, 286, 458 | 100% |  | 2024-01-19 | 2024-01-19 | 0d | 2024-01-22 | 2024-01-22 |  |  |  | SI Test | PP,IPA | SIT | 5.15 |  | Systems Integration Testing (SIT) | Complete | COMPLETE | MHHS-ART071 | T2-TE-0500 | SITAG | T2 |
| 828 | 1.4.1.4.2 | **SIT Functional Preparation** |  | 595d? | 2022-10-31 A | 2025-02-07 |  | 99% | 3.83d? | 2022-10-31 | 2025-04-07 | 520d | 2022-10-31 | 2024-03-01 | 749d |  | -0 | N/A | N/A | SIT | 5.0 | N/A | Systems Integration Testing (SIT) |  |  |  |  | SITAG |  |
| 829 | 1.4.1.4.2.1 | Environment Approach and Plan - SIT Functional |  | 1d? | 2023-11-20 A | 2023-11-20 A |  | 100% |  | 2023-11-20 | 2023-11-20 | 0d |  |  |  | start no earlier than 2023-11-20 |  | SI Test |  | SIT | 6.0 |  |  | Complete | COMPLETE |  |  |  |  |
| 830 | 1.4.1.4.2.2 | **Test Approach & Plan** |  | 208d | 2022-10-31 A | 2023-08-16 A |  | 100% |  | 2022-10-31 | 2023-08-16 | 208d | 2022-10-31 | 2023-08-16 |  |  |  | N/A | N/A | SIT | 5.0 | N/A | Systems Integration Testing (SIT) |  |  |  |  |  |  |
| 831 | 1.4.1.4.2.2.1 | Develop document with SITWG |  | 179d | 2022-10-31 A | 2023-07-06 A |  | 100% |  | 2022-10-31 | 2023-07-06 | 179d | 2022-10-31 | 2023-07-06 |  | finish no earlier than 2023-07-06 |  | SI Test |  | SIT | 5.0 |  | Systems Integration Testing (SIT) | Complete | COMPLETE |  |  |  |  |
| 832 | 1.4.1.4.2.2.2 | Industry Consultation |  | 10d | 2023-07-07 A | 2023-07-20 A | 831 | 100% |  | 2023-07-07 | 2023-07-20 | 10d |  |  |  |  |  | PP |  | SIT | 5.1 |  | Systems Integration Testing (SIT) | Complete | COMPLETE |  |  |  |  |
| 833 | 1.4.1.4.2.2.3 | Artefact review (via TMAG) and updates |  | 19d | 2023-07-21 A | 2023-08-16 A | 832 | 100% |  | 2023-07-21 | 2023-08-16 | 19d | 2023-07-07 | 2023-08-03 |  | finish no earlier than 2023-08-03 |  | SI Test | PP,IPA,Code Bodies | SIT | 5.5 |  | Systems Integration Testing (SIT) | Complete | COMPLETE |  |  |  |  |
| 834 | 1.4.1.4.2.2.4 | SIT Functional Test Approach & Plan approved | milestone | 0d | 2023-08-16 A | 2023-08-16 A |  | 100% |  | 2023-08-16 | 2023-08-16 | 0d | 2023-08-16 | 2023-08-16 |  | finish no earlier than 2023-08-16 |  | SI Test | PP | SIT | 5.0 |  | Systems Integration Testing (SIT) | Complete | COMPLETE | MHHS-ART073 | T3-TE-0013 | SITAG | T3 |

Notes:
- 818: Action: 28/7: CH: Needs to be set-up as a reporting milestone. 31/7: Check with Cesar if has been approved so can be baselined

| ID | WBS | Task | Type | Duration | Start | Finish | Predecessors | Complete | Remaining | Baseline start | Baseline finish | Baseline duration | Baseline 1 start | Baseline 1 finish | Total slack | Free slack | Constraint | Baseline cost | Responsible | Involved | Text9 | Update Version | MHHS Resource Name | MHHS Programme Phase | Sched Status | RAG | Artefact ID | Milestone ID | Text29 | Tier | Action | Guidance | Task Status |
| --- | --- | --- | --- | --- | --- | --- | --- | --- | --- | --- | --- | --- | --- | --- | --- | --- | --- | --- | --- | --- | --- | --- | --- | --- | --- | --- | --- | --- | --- | --- | --- | --- | --- |
| 835 | 1.4.1.4.2.3 | **Test Data Approach & Plan** |  | 29d | 2023-07-07 A | 2023-08-16 A |  | 100% |  | 2023-07-07 | 2023-08-16 | 29d | 2023-07-07 | 2023-08-16 |  |  |  |  | N/A | N/A | SIT | 5.0 | N/A | Systems Integration Testing (SIT) |  |  |  |  |  |  |  |  |  |
| 836 | 1.4.1.4.2.3.1 | Industry Consultation |  | 10d | 2023-07-07 A | 2023-07-20 A | 832SS | 100% |  | 2023-07-07 | 2023-07-20 | 10d |  |  |  |  |  |  | PP |  | SIT | 5.1 | Cesar Lopes | Systems Integration Testing (SIT) | Complete | COMPLETE |  |  |  |  |  |  |  |
| 837 | 1.4.1.4.2.3.2 | Artefact review (via TMAG) and updates |  | 19d | 2023-07-21 A | 2023-08-16 A | 836 | 100% |  | 2023-07-21 | 2023-08-16 | 19d | 2023-07-07 | 2023-08-03 |  |  |  |  | SI Test |  | SIT | 5.5 | Cesar Lopes | Systems Integration Testing (SIT) | Complete | COMPLETE |  |  |  |  |  |  |  |
| 838 | 1.4.1.4.2.3.3 | SIT Functional Testing Test Data Approach & Plan approved | milestone | 0d | 2023-08-16 A | 2023-08-16 A | 837 | 100% |  | 2023-08-16 | 2023-08-16 | 0d | 2023-08-16 | 2023-08-16 |  |  |  |  | SI Test | PP,IPA | SIT | 5.5 | Cesar Lopes | Systems Integration Testing (SIT) | Complete | COMPLETE |  |  |  |  |  |  |  |
| 839 | 1.4.1.4.2.4 | **Test scenarios** |  | 298d | 2023-01-02 A | 2024-02-21 A |  | 100% |  | 2023-01-02 | 2024-02-21 | 298d | 2023-01-02 | 2023-06-02 |  |  |  | -0 | N/A | N/A | SIT | 5.0 | N/A | Systems Integration Testing (SIT) |  |  |  |  |  |  |  |  |  |
| 840 | 1.4.1.4.2.4.1 | Development of test scenarios |  | 85d | 2023-01-02 A | 2023-04-28 A | 831SS+45d | 100% |  | 2023-01-02 | 2023-04-28 | 85d | 2023-01-02 | 2023-04-28 |  |  |  |  | SI Test | PP, Code Bodies | SIT | 5.0 |  | Systems Integration Testing (SIT) | Complete | COMPLETE |  |  |  |  |  |  |  |
| 841 | 1.4.1.4.2.4.2 | Review test scenarios with SIT Working Group |  | 65d | 2023-08-17 A | 2023-11-15 A | 840FS+78d | 100% |  | 2023-08-17 | 2023-11-15 | 65d | 2023-02-01 | 2023-05-26 |  |  |  |  | SI Test | PP, Code Bodies, IPA | SIT | 5.0 |  | Systems Integration Testing (SIT) | Complete | COMPLETE |  |  |  |  |  |  |  |
| 842 | 1.4.1.4.2.4.3 | SIT Functional Testing Test scenarios (themes 1-5) approved | milestone | 0d | 2023-12-08 A | 2023-12-08 A | 841FS+17d | 100% |  | 2023-12-08 | 2023-12-08 | 0d | 2023-06-02 | 2023-06-02 |  |  |  |  | SI Test | PP | SIT | 5.14 |  | Systems Integration Testing (SIT) | Complete | COMPLETE | MMHS-ART073 | T3-TE-0015 | SITAG | T3 |  |  |  |
| 843 | 1.4.1.4.2.4.4 | SIT Functional Testing Test scenarios (themes 6,7,9) approved | milestone | 0d | 2024-01-17 A | 2024-01-17 A | 842FS+28d | 100% |  | 2024-01-17 | 2024-01-17 | 0d | 2023-06-02 | 2023-06-02 |  |  |  |  | SI Test | PP | SIT | 5.16 |  | Systems Integration Testing (SIT) | Complete | COMPLETE | MMHS-ART073 | T3-TE-0106 | SITAG | T3 |  |  |  |
| 844 | 1.4.1.4.2.4.5 | SIT Functional Testing Test scenarios (theme 8) approved | milestone | 0d | 2024-02-21 A | 2024-02-21 A | 843FS+25d | 100% |  | 2024-02-21 | 2024-02-21 | 0d | 2023-06-02 | 2023-06-02 |  |  |  |  | SI Test | PP | SIT | 5.14 |  | Systems Integration Testing (SIT) | Complete | COMPLETE | MMHS-ART073 | T3-TE-0107 | SITAG | T3 |  |  |  |
| 845 | 1.4.1.4.2.5 | **Test cases** |  | 465d? | 2023-05-01 A | 2025-02-07 |  | 98% | 7.93d? | 2023-05-01 | 2025-02-07 | 213d | 2023-05-01 | 2023-09-01 | 749d |  |  |  | N/A | N/A | SIT | 5.0 | N/A | Systems Integration Testing (SIT) |  |  |  |  |  |  | 25/7 - needs to be replanned |  |  |
| 846 | 1.4.1.4.2.5.1 | **SI Test cases** |  | 213d | 2023-05-01 A | 2024-02-21 A |  | 100% |  | 2023-05-01 | 2024-02-21 | 213d | 2023-05-01 | 2023-09-01 |  |  |  |  | N/A | N/A | SIT | 5.0 | N/A | Systems Integration Testing (SIT) |  |  |  |  |  |  | 25/7 - needs to be replanned |  |  |
| 847 | 1.4.1.4.2.5.1.1 | Development of Test cases |  | 150d | 2023-05-01 A | 2023-11-24 A | 840 | 100% |  | 2023-05-01 | 2023-11-24 | 150d | 2023-05-01 | 2023-07-28 |  |  |  |  | SI Test |  | SIT | 5.0 |  | Systems Integration Testing (SIT) | Complete | COMPLETE |  |  |  |  | 25/7 - needs to be replanned |  |  |
| 848 | 1.4.1.4.2.5.1.2 | Review Test cases with SIT Working Group |  | 78d | 2023-09-25 A | 2024-01-10 A | 847SS+105d | 100% |  | 2023-09-25 | 2024-01-10 | 78d | 2023-05-26 | 2023-08-25 |  |  |  |  | SI Test | PP,IPA | SIT | 5.0 |  | Systems Integration Testing (SIT) | Complete | COMPLETE |  |  |  |  | 25/7 - needs to be replanned |  |  |
| 849 | 1.4.1.4.2.5.1.3 | SIT Functional Testing Test Cases (themes 1-5) approved | milestone | 0d | 2024-01-17 A | 2024-01-17 A | 848FS+5d | 100% |  | 2024-01-17 | 2024-01-17 | 0d | 2023-09-01 | 2023-09-01 |  |  |  |  | SI Test | PP | SIT | 5.14 |  | Systems Integration Testing (SIT) | Complete | COMPLETE | MHHS-ART140 | T3-TE-0070 | SITAG | T3 |  | 2/1/24 - Approved at Dec TMAG |  |
| 850 | 1.4.1.4.2.5.1.4 | SIT Functional Testing Test cases (themes 6,7,9) approved | milestone | 0d | 2024-01-17 A | 2024-01-17 A | 849 | 100% |  | 2024-01-17 | 2024-01-17 | 0d | 2023-09-01 | 2023-09-01 |  |  |  |  | SI Test | PP | SIT | 5.14 |  | Systems Integration Testing (SIT) | Complete | COMPLETE | MHHS-ART140 | T3-TE-0108 | SITAG | T3 |  |  |  |
| 851 | 1.4.1.4.2.5.1.5 | SIT Functional Testing Test cases (theme 8) approved | milestone | 0d | 2024-02-21 A | 2024-02-21 A | 850FS+25d | 100% |  | 2024-02-21 | 2024-02-21 | 0d | 2023-09-01 | 2023-09-01 |  |  |  |  | SI Test | PP | SIT | 5.14 |  | Systems Integration Testing (SIT) | Complete | COMPLETE | MHHS-ART140 | T3-TE-0109 | SITAG | T3 |  |  |  |
| 852 | 1.4.1.4.2.5.2 | **SIT Functional Programme RTTM** |  | 74d? | 2024-07-29 A | 2024-11-07 |  | 95% | 3.41d? | 2024-07-29 | 2024-10-11 | 0d |  |  | 815d |  |  |  | SI Test |  | SIT | 6.0 | Kevin Davis |  | Overdue Start |  |  |  | SITAG |  |  |  | -687.67 |
| 853 | 1.4.1.4.2.5.2.1 | **RTTM Development** |  | 40d? | 2024-07-29 A | 2024-09-20 |  | 89% | 4.57d? | 2024-07-29 | 2024-09-20 | 0d |  |  | 849d |  |  |  | SI Test |  | SIT | 6.0 | Kevin Davis |  | Overdue Start |  |  |  | SITAG |  |  |  | -693.67 |
| 854 | 1.4.1.4.2.5.2.1.1 | Development of Manual SIT Functional RTTM |  | 30d? | 2024-07-29 A | 2024-09-06 A |  | 100% |  | 2024-07-29 | 2024-09-06 | 0d |  |  |  |  | start no earlier than 2024-07-29 |  | SI Test |  | SIT | 6.0 | Kevin Davis |  | Complete | COMPLETE |  |  | SITAG |  |  |  |  |
| 855 | 1.4.1.4.2.5.2.1.2 | Manual SIT Functional RTTM Complete | milestone | 0d? | 2024-09-06 A | 2024-09-06 A | 854 | 100% |  | 2024-09-06 | 2024-09-06 | 0d |  |  |  |  | start no earlier than 2024-07-29 |  | SI Test |  | SIT | 6.0 | Kevin Davis |  | Complete | COMPLETE |  |  | SITAG |  |  |  |  |
| 856 | 1.4.1.4.2.5.2.1.3 | Development of Automated SIT Functional RTTM |  | 40d? | 2024-07-29 A | 2024-09-20 |  | 80% | 8d? | 2024-07-29 | 2024-09-20 | 0d |  |  | 849d | 0d | start no earlier than 2024-07-29 |  | SI Test |  | SIT | 6.0 | Roger Robar / Heath Thomas |  | Overdue | RED |  |  | SITAG |  |  |  |  |
| 857 | 1.4.1.4.2.5.2.1.4 | Automated SIT Functional RTTM Complete | milestone | 0d? | 2024-09-20 A | 2024-09-20 | 856 | 80% | 0d? | 2024-09-20 | 2024-09-20 | 0d |  |  | 849d |  | finish no earlier than 2024-09-20 |  | SI Test |  | SIT | 6.0 | Roger Robar / Heath Thomas |  | Overdue | RED |  |  | SITAG |  |  |  |  |
| 858 | 1.4.1.4.2.5.2.2 | **Gap analysis** |  | 54d? | 2024-08-26 A | 2024-11-07 |  | 99% | 0.12d? | 2024-08-26 | 2024-10-11 | 0d |  |  | 123d |  |  |  | SI Test |  | SIT | 6.0 | Kevin Davis |  | Overdue Start |  |  |  | SITAG |  |  |  | -693.67 |
| 859 | 1.4.1.4.2.5.2.2.1 | Identify gaps in test case coverage following RTTM review |  | 20d? | 2024-08-26 A | 2024-09-20 A | 856SS+20d | 100% |  | 2024-08-26 | 2024-09-20 | 0d |  |  |  |  |  |  | SI Test |  | SIT | 6.0 | Kevin Davis |  | Complete | COMPLETE |  |  | SITAG |  |  |  |  |
| 860 | 1.4.1.4.2.5.2.2.2 | Address gaps in test case coverage following RTTM review |  | 25d | 2024-09-09 A | 2024-10-11 A | 859SS+10d | 100% |  | 2024-09-09 | 2024-10-04 | 0d |  |  |  |  |  |  | SI Test |  | SIT | 6.0 | Kevin Davis |  | Complete | COMPLETE |  |  | SITAG |  |  |  |  |
| 861 | 1.4.1.4.2.5.2.2.3 | Gap analysis complete | milestone | 0d | 2024-10-11 A | 2024-10-11 A | 860 | 100% |  | 2024-10-11 | 2024-10-11 | 0d |  |  |  |  |  |  | SI Test |  | SIT | 6.11 | Kevin Davis |  | Complete | COMPLETE |  |  | SITAG |  |  |  |  |
| 862 | 1.4.1.4.2.5.2.2.4 | Test Script updates identified |  | 1d? | 2024-10-14 A | 2024-10-14 A | 861 | 100% |  | 2024-10-14 | 2024-10-14 | 0d |  |  |  |  |  |  | SI Test |  | SIT | 6.11 | Kevin Davis |  | Complete | COMPLETE |  |  | SITAG |  |  |  |  |
| 863 | 1.4.1.4.2.5.2.2.5 | Test Scripts updates |  | 1d | 2024-10-15 A | 2024-10-15 A | 862 | 100% |  | 2024-10-15 | 2024-10-15 | 0d |  |  |  |  |  |  | SI Test |  | SIT | 6.11 | Kevin Davis |  | Complete | COMPLETE |  |  | SITAG |  |  |  |  |
| 864 | 1.4.1.4.2.5.2.2.6 | RTTM Updated Additional Static RTTM WBS items |  | 10d | 2024-10-14 A | 2024-10-25 A | 862FS-1d | 100% |  | 2024-10-14 | 2024-10-25 | 0d |  |  |  |  |  |  | SI Test |  | SIT | 6.11 | Kevin Davis |  | Complete | COMPLETE |  |  | SITAG |  |  |  |  |
| 865 | 1.4.1.4.2.5.2.2.7 | Removal of de-scoped TCs from the RTTMs |  | 5d | 2024-10-21 A | 2024-10-25 A | 864FS-5d | 100% |  | 2024-10-21 | 2024-10-25 | 0d |  |  |  |  |  |  | SI Test |  | SIT | 6.11 | Kevin Davis |  | Complete | COMPLETE |  |  | SITAG |  |  |  |  |
| 866 | 1.4.1.4.2.5.2.2.8 | Update and stabilisation of all TC ADO IDs |  | 14d | 2024-10-21 A | 2024-11-07 A | 864FS-5d | 100% |  | 2024-10-21 | 2024-10-25 | 0d |  |  |  |  |  |  | SI Test |  | SIT | 6.12 | Kevin Davis |  | Complete | COMPLETE |  |  | SITAG |  |  |  |  |
| 867 | 1.4.1.4.2.5.2.2.9 | Addition and integration of Role tags to reqs in the Role RTTMs |  | 5d | 2024-10-21 A | 2024-10-25 A | 864FS-5d | 100% |  | 2024-10-21 | 2024-10-25 | 0d |  |  |  |  |  |  | SI Test |  | SIT | 6.11 | Kevin Davis |  | Complete | COMPLETE |  |  | SITAG |  |  |  |  |
| 868 | 1.4.1.4.2.5.2.2.10 | Update of the RTTM All sheet (porting of the individual RTTMs) |  | 7d | 2024-10-24 A | 2024-11-01 A | 864FS-2d | 100% |  | 2024-10-24 | 2024-10-25 | 0d |  |  |  |  |  |  | SI Test |  | SIT | 6.11 | Kevin Davis |  | Complete | COMPLETE |  |  | SITAG |  |  |  |  |
| 869 | 1.4.1.4.2.5.2.2.11 | Define Additional ADO Tags |  | 1d | 2024-10-23 A | 2024-10-23 A | 864FS-3d | 100% |  | 2024-10-23 | 2024-10-23 | 0d |  |  |  |  |  |  | SI Test |  | SIT | 6.11 | Kevin Davis |  | Complete | COMPLETE |  |  | SITAG |  |  |  |  |
| 870 | 1.4.1.4.2.5.2.2.12 | Functional RTTM ready for import into ADO | milestone | 0d | 2024-11-01 A | 2024-11-01 A | 868 | 100% |  | 2024-10-25 | 2024-10-25 | 0d |  |  |  |  |  |  | SI Test |  | SIT | 6.11 | Kevin Davis |  | Complete | COMPLETE |  |  | SITAG |  |  |  |  |
| 871 | 1.4.1.4.2.5.2.2.13 | Further Interative Deepdive on the requirements to testcase mapping |  | 9d | 2024-10-21 A | 2024-10-31 A | 868FS-10d | 100% |  | 2024-10-21 | 2024-10-31 | 0d |  |  |  |  |  |  | SI Test |  | SIT | 6.11 | Kevin Davis |  | Complete | COMPLETE |  |  | SITAG |  |  |  |  |
| 872 | 1.4.1.4.2.5.2.2.14 | Internal review |  | 5d | 2024-10-21 A | 2024-10-25 A | 871FS-9d | 100% |  | 2024-11-01 | 2024-11-05 | 0d |  |  |  |  |  |  | SI Test |  | SIT | 6.11 | Kevin Davis |  | Complete | COMPLETE |  |  | SITAG |  |  |  |  |
| 873 | 1.4.1.4.2.5.2.2.15 | Issue Static RTTM to Code Bodies |  | 1d? | 2024-10-29 A | 2024-10-29 A | 872FS+1d | 100% |  | 2024-11-06 | 2024-11-06 | 0d |  |  |  |  |  |  | SI Test |  | SIT | 6.11 | Kevin Davis |  | Complete | COMPLETE |  |  | SITAG |  |  |  |  |
| 874 | 1.4.1.4.2.5.2.2.16 | Code Body Acceptance of RTTM |  | 5d | 2024-10-30 A | 2024-11-05 | 873 | 95% | 0.25d | 2024-11-07 | 2024-11-13 | 0d |  |  | 125d | 0d |  |  | Code Bodies |  | SIT | 6.11 | Kevin Davis |  | Green | RED |  |  |  |  |  |  |  |

Notes:
- 857: 06/11/24 - Action taken for Programme to work with SRO to define the purpose of the automated RTTM.
- 866: 06/11/24 - Target date for completion 07/11/24, personnel illness has meant this has slipped. Forecast updated.
- 868: 06/11/24 - All Sheet was updated, but further updates required before this can be completed, due to delay of Update and stabilisation of all TC ADO IDs
- 874: 13/11/25 - This has been issued to Code Bodies on 13/10/24, but a final outstanding issue needs to be resolved before it's officially accepted.

| ID | WBS | Task | Type | Duration | Start | Finish | Predecessors | Complete | Baseline start | Baseline finish | Baseline duration | Constraint | Responsible | Text9 | Task Status | Update Version | Sched Status | MHHS Resource Name | RAG | Milestone ID |
| --- | --- | --- | --- | --- | --- | --- | --- | --- | --- | --- | --- | --- | --- | --- | --- | --- | --- | --- | --- | --- |
| 875 | 1.4.1.4.2.5.3 | **Cycle 3 Test Evidence Capturing Approach** |  | 25d? | 2024-09-16 A | 2024-10-18 A |  | 100% | 2024-09-16 | 2024-10-18 | 0d |  | SI Test | SIT | -692.67 | 6.0 | Overdue Start | Ankur Pande |  |  |
| 876 | 1.4.1.4.2.5.3.1 | Define guiding principles and proof of concept |  | 10d | 2024-09-16 A | 2024-09-27 A |  | 100% | 2024-09-16 | 2024-09-27 | 0d | start no earlier than 2024-09-16 | SI Test | SIT |  | 6.0 | Complete | Ankur Pande | COMPLETE |  |
| 877 | 1.4.1.4.2.5.3.2 | Draft proposed test evidence capturing approach |  | 3d | 2024-09-30 A | 2024-10-02 A | 876 | 100% | 2024-09-30 | 2024-10-02 | 0d |  | SI Test | SIT |  | 6.0 | Complete | Ankur Pande | COMPLETE |  |
| 878 | 1.4.1.4.2.5.3.3 | SRO review |  | 5d | 2024-10-03 A | 2024-10-09 A | 877 | 100% | 2024-10-03 | 2024-10-09 | 0d |  | SI Test | SIT |  | 6.0 | Complete | Ankur Pande | COMPLETE |  |
| 879 | 1.4.1.4.2.5.3.4 | Present proposed approach |  | 1d? | 2024-10-11 A | 2024-10-11 A | 878FS+1d | 100% | 2024-10-11 | 2024-10-11 | 0d |  | SI Test | SIT |  | 6.0 | Complete | Ankur Pande | COMPLETE |  |
| 880 | 1.4.1.4.2.5.3.5 | Incorporate feedback |  | 4d | 2024-10-14 A | 2024-10-17 A | 879 | 100% | 2024-10-14 | 2024-10-17 | 0d |  | SI Test | SIT |  | 6.0 | Complete | Ankur Pande | COMPLETE |  |
| 881 | 1.4.1.4.2.5.3.6 | Publish proposed approach ahead of Cycle 3 start |  | 1d? | 2024-10-18 A | 2024-10-18 A | 880 | 100% | 2024-10-18 | 2024-10-18 | 0d |  | SI Test | SIT |  | 6.0 | Complete | Ankur Pande | COMPLETE |  |
| 882 | 1.4.1.4.2.5.4 | **DITL Cycle 3 Pack Development** |  | 8d? | 2024-10-08 A | 2024-10-17 A |  | 100% | 2024-10-08 | 2024-10-17 | 0d |  | SI Test | SIT | 6.33 | 6.0 | No BL | Dom Mooney |  |  |
| 883 | 1.4.1.4.2.5.4.1 | Programme Cycle 2 Retro |  | 1d? | 2024-10-08 A | 2024-10-08 A |  | 100% | 2024-10-08 | 2024-10-08 | 0d | start no earlier than 2024-10-08 | SI Test | SIT |  | 6.0 | Complete | Dom Mooney | COMPLETE |  |
| 884 | 1.4.1.4.2.5.4.2 | Post-retro DITL Changes |  | 3d | 2024-10-09 A | 2024-10-11 A | 883 | 100% | 2024-10-09 | 2024-10-11 | 0d |  | SI Test | SIT |  | 6.0 | Complete | Dom Mooney | COMPLETE |  |
| 885 | 1.4.1.4.2.5.4.3 | SRO Review |  | 2d | 2024-10-14 A | 2024-10-15 A | 884 | 100% | 2024-10-14 | 2024-10-15 | 0d |  | SI Test | SIT |  | 6.0 | Complete | Dom Mooney | COMPLETE |  |
| 886 | 1.4.1.4.2.5.4.4 | Post-SRO Review Changes |  | 1d? | 2024-10-16 A | 2024-10-16 A | 885 | 100% | 2024-10-16 | 2024-10-16 | 0d |  | SI Test | SIT |  | 6.0 | Complete | Dom Mooney | COMPLETE |  |
| 887 | 1.4.1.4.2.5.4.5 | Publish Cycle 3 DITL / Cycle 3 DITL Online Sessions for SIT PPs |  | 1d? | 2024-10-17 A | 2024-10-17 A | 886 | 100% | 2024-10-17 | 2024-10-17 | 0d |  | SI Test, PPs | SIT |  | 6.0 | Complete | Dom Mooney | COMPLETE |  |
| 888 | 1.4.1.4.2.5.5 | **Test Script Exit Points** |  | 85d | 2024-10-14 A | 2025-02-07 A |  | 100% | 2024-10-14 | 2025-02-07 | 0d |  | SI Test | SIT | -694.67 | 6.0 | Overdue Start | Kevin Davis |  |  |
| 889 | 1.4.1.4.2.5.5.1 | Implement exit points for Sprint 5 |  | 5d | 2024-10-14 A | 2024-10-18 A | 881FS-5d | 100% | 2024-10-14 | 2024-10-18 | 0d |  | SI Test | SIT |  | 6.0 | Complete | Kevin Davis | COMPLETE |  |
| 890 | 1.4.1.4.2.5.5.2 | Identify exit points for Sprint 6 |  | 5d | 2024-11-07 A | 2024-11-13 A | 1462SS | 100% | 2024-10-21 | 2024-10-25 | 0d |  | SI Test | SIT |  | 6.0 | Complete | Kevin Davis | COMPLETE |  |
| 891 | 1.4.1.4.2.5.5.3 | Identify exit points for Sprint 7 |  | 5d | 2024-11-08 A | 2024-11-14 A | 1463SS | 100% | 2024-11-04 | 2024-11-08 | 0d | start no earlier than 2024-11-08 | SI Test | SIT |  | 6.0 | Complete | Kevin Davis | COMPLETE |  |
| 892 | 1.4.1.4.2.5.5.4 | Identify exit points for Sprint 8 |  | 5d | 2024-11-18 A | 2024-11-22 A | 1464SS | 100% | 2024-11-18 | 2024-11-22 | 0d |  | SI Test | SIT |  | 6.0 | Complete | Kevin Davis | COMPLETE |  |
| 893 | 1.4.1.4.2.5.5.5 | Identify exit points for Sprint 9 |  | 5d | 2024-12-02 A | 2024-12-06 A | 1465SS | 100% | 2024-12-02 | 2024-12-06 | 0d |  | SI Test | SIT |  | 6.0 | Complete | Kevin Davis | COMPLETE |  |
| 894 | 1.4.1.4.2.5.5.6 | Identify exit points for Sprint 10 |  | 5d | 2024-12-23 A | 2024-12-27 A | 1466SS | 100% | 2024-12-23 | 2024-12-27 | 0d |  | SI Test | SIT |  | 6.0 | Complete | Kevin Davis | COMPLETE |  |
| 895 | 1.4.1.4.2.5.5.7 | Identify exit points for Sprint 11 |  | 5d | 2025-01-06 A | 2025-01-10 A | 1467SS | 100% | 2025-01-06 | 2025-01-10 | 0d |  | SI Test | SIT |  | 6.0 | Complete | Kevin Davis | COMPLETE |  |
| 896 | 1.4.1.4.2.5.5.8 | Identify exit points for Sprint 12 |  | 5d | 2025-01-20 A | 2025-01-24 A | 1468SS | 100% | 2025-01-20 | 2025-01-24 | 0d |  | SI Test | SIT |  | 6.0 | Complete | Kevin Davis | COMPLETE |  |
| 897 | 1.4.1.4.2.5.5.9 | Identify exit points for Sprint 13 |  | 5d | 2025-02-03 A | 2025-02-07 A | 1469SS | 100% | 2025-02-03 | 2025-02-07 | 0d |  | SI Test | SIT |  | 6.0 | Complete | Kevin Davis | COMPLETE |  |
| 898 | 1.4.1.4.2.5.5.10 | Exit point identified and evidence capture flags updated | milestone | 0d | 2025-02-07 A | 2025-02-07 A | 897 | 100% | 2025-02-07 | 2025-02-07 | 0d |  |  | SIT |  | 6.13 | Complete |  | COMPLETE | T3-TE-0125 |

Notes:
- 890: 20/11/2024 - Activity complete.
- 891: 20/11/2024 - Activity complete.
- 892: 20/11/2024 - Activity complete.
- 893: 20/11/2024 - Activity complete ahead of schedule.
- 894: 20/11/2024 - Activity complete ahead of schedule.
- 895: 20/11/2024 - Activity complete ahead of schedule.
- 896: 20/11/2024 - Activity complete ahead of schedule.
- 897: 20/11/2024 - Activity complete ahead of schedule.
- 898: 20/11/2024 - Activity complete ahead of schedule.

| ID | WBS | Task | Type | Duration | Start | Finish | Predecessors | Complete | Baseline start | Baseline finish | Baseline duration | Baseline 1 start | Baseline 1 finish | Constraint | Baseline cost | Responsible | Involved | Text9 | Update Version | MHHS Resource Name | MHHS Programme Phase | Task Status | Sched Status | RAG | Action | Milestone ID | Text29 | Tier | Artefact ID |
| --- | --- | --- | --- | --- | --- | --- | --- | --- | --- | --- | --- | --- | --- | --- | --- | --- | --- | --- | --- | --- | --- | --- | --- | --- | --- | --- | --- | --- | --- |
| 899 | 1.4.1.4.2.6 | **Environments (SIT-Staging)** |  | 10d | 2023-12-04 A | 2023-12-15 A |  | 100% | 2023-12-04 | 2023-12-15 | 323d | 2022-11-16 | 2024-02-09 |  |  | N/A | N/A | SIT | 5.0 | N/A | Systems Integration Testing (SIT) |  |  |  |  |  |  |  |  |
| 900 | 1.4.1.4.2.6.1 | **SIT Functional pre-requisites** |  | 10d | 2023-12-04 A | 2023-12-15 A |  | 100% | 2023-12-04 | 2023-12-15 | 10d |  |  |  |  | N/A | N/A | SIT | 5.3 | N/A | Systems Integration Testing (SIT) |  |  |  |  |  |  |  |  |
| 901 | 1.4.1.4.2.6.1.1 | **DCC** |  | 10d | 2023-12-04 A | 2023-12-15 A |  | 100% | 2023-12-04 | 2023-12-15 | 10d |  |  |  |  | N/A | N/A | SIT | 5.3 | N/A | Systems Integration Testing (SIT) | -254.67 |  |  |  |  |  |  |  |
| 902 | 1.4.1.4.2.6.1.1.1 | **CSS** |  | 10d | 2023-12-04 A | 2023-12-15 A |  | 100% | 2023-12-04 | 2023-12-15 | 10d |  |  |  |  | N/A | N/A | SIT | 5.3 | N/A | Systems Integration Testing (SIT) | -254.67 |  |  |  |  |  |  |  |
| 903 | 1.4.1.4.2.6.1.1.1.1 | SIT participants have requested DCC CSS PKI certificates for access to UIT-B environment |  | 10d | 2023-12-04 A | 2023-12-15 A |  | 100% | 2023-12-04 | 2023-12-15 | 10d |  |  | start no earlier than 2023-12-04 |  | SIT Participants (Suppliers & Third Parties) | PP | SIT | 5.3 | Simon Berry | Systems Integration Testing (SIT) |  | Complete | COMPLETE |  |  |  |  |  |
| 904 | 1.4.1.4.2.6.1.1.1.2 | SIT participants have received DCC CSS PKI certificates for UIT-B environment | milestone | 0d | 2023-12-15 A | 2023-12-15 A | 903 | 100% | 2023-12-15 | 2023-12-15 | 0d |  |  |  |  | SIT Participants (Suppliers & Third Parties) | PP | SIT | 5.5 | Simon Berry | Systems Integration Testing (SIT) |  | Complete | COMPLETE | 7/8 - added as a T3 milestone. Awaiting approval at TMAG | T3-TE-0088 | SITAG | T3 |  |
| 905 | 1.4.1.4.2.6.1.1.2 | **DSP** |  | 10d | 2023-12-04 A | 2023-12-15 A |  | 100% | 2023-12-04 | 2023-12-15 | 10d |  |  |  |  | N/A | N/A | SIT | 5.3 | N/A | Systems Integration Testing (SIT) | -254.67 |  |  |  |  |  |  |  |
| 906 | 1.4.1.4.2.6.1.1.2.1 | SIT participants have requested DCC DSP PKI certificates for access to UIT-B environment |  | 10d | 2023-12-04 A | 2023-12-15 A |  | 100% | 2023-12-04 | 2023-12-15 | 10d |  |  | start no earlier than 2023-12-04 |  | PPs in SDS Market Role | PP | SIT | 5.3 | Simon Berry | Systems Integration Testing (SIT) |  | Complete | COMPLETE |  |  |  |  |  |
| 907 | 1.4.1.4.2.6.1.1.2.2 | SIT participants have received DCC DSP PKI certificates for UIT-B environment | milestone | 0d | 2023-12-15 A | 2023-12-15 A | 906 | 100% | 2023-12-15 | 2023-12-15 | 0d |  |  |  |  | PPs in SDS Market Role | PP | SIT | 5.5 | Simon Berry | Systems Integration Testing (SIT) |  | Complete | COMPLETE | 7/8 - added as a T3 milestone. Awaiting approval at TMAG | T3-TE-0089 | SITAG | T3 |  |
| 908 | 1.4.1.4.2.7 | **Stand up SIT A Environment** |  | 25d | 2024-02-05 A | 2024-03-08 A |  | 100% | 2024-02-05 | 2024-03-08 | 25d | 2024-02-05 | 2024-02-09 |  |  | N/A | N/A | SIT | 6.0 | N/A | Systems Integration Testing (SIT) |  |  |  |  |  |  |  |  |
| 909 | 1.4.1.4.2.7.1 | **SIT Functional Connectivity Proving** |  | 15d | 2024-02-12 A | 2024-03-01 A |  | 100% | 2024-02-12 | 2024-03-01 | 20d |  |  |  |  | N/A | N/A | SIT | 5.5 | N/A | Systems Integration Testing (SIT) | -288.67 |  |  |  |  |  |  |  |
| 910 | 1.4.1.4.2.7.1.1 | SIT Functional Connectivity Proving Period |  | 15d | 2024-02-12 A | 2024-03-01 A |  | 100% | 2024-02-12 | 2024-03-01 | 20d |  |  | start no earlier than 2024-01-08 |  | SI Test | PP | SIT | 5.19 | Simon Berry | Systems Integration Testing (SIT) |  | Complete | COMPLETE |  |  |  |  |  |
| 911 | 1.4.1.4.2.7.1.2 | SIT Functional Connectivity Proving Complete | milestone | 0d | 2024-03-01 A | 2024-03-01 A | 910 | 100% | 2024-03-01 | 2024-03-01 | 0d |  |  | start no earlier than 2024-03-01 |  | SI Test | PP | SIT | 5.19 | Simon Berry | Systems Integration Testing (SIT) |  | Complete | COMPLETE |  | T3-TE-0103 | SITAG | T3 |  |
| 912 | 1.4.1.4.2.7.2 | **PP Environments (SIT A)** |  | 25d | 2024-02-05 A | 2024-03-08 A |  | 100% | 2024-02-05 | 2024-03-08 | 5d | 2024-02-05 | 2024-02-09 |  |  | N/A | N/A | SIT | 5.0 | N/A | Systems Integration Testing (SIT) |  |  |  |  |  |  |  |  |
| 913 | 1.4.1.4.2.7.2.1 | Deployment of MHHS solution code to SIT A environments |  | 25d | 2024-02-05 A | 2024-03-08 A |  | 100% | 2024-02-05 | 2024-03-08 | 5d | 2024-02-05 | 2024-02-09 | start no earlier than 2024-02-05 |  | PP | SI Test | SIT | 5.0 | Simon Berry | Systems Integration Testing (SIT) |  | Complete | COMPLETE |  |  |  |  |  |
| 914 | 1.4.1.4.2.7.3 | **SI Environments (SIT A)** |  | 25d | 2024-02-05 A | 2024-03-08 A |  | 100% | 2024-02-05 | 2024-03-08 | 5d | 2024-02-05 | 2024-02-09 |  |  | N/A | N/A | SIT | 5.0 | N/A | Systems Integration Testing (SIT) |  |  |  |  |  |  |  |  |
| 915 | 1.4.1.4.2.7.3.1 | Coordinate deployment of MHHS solution code to SIT Participants' SIT A environments |  | 25d | 2024-02-05 A | 2024-03-08 A | 913SS | 100% | 2024-02-05 | 2024-03-08 | 5d | 2024-02-05 | 2024-02-09 |  |  | SI Test | PP | SIT | 5.0 | Simon Berry | Systems Integration Testing (SIT) |  | Complete | COMPLETE |  |  |  |  |  |
| 916 | 1.4.1.4.2.8 | **Test data (SIT A)** |  | 221d? | 2023-12-18 A | 2024-10-21 A |  | 100% | 2023-12-18 | 2025-04-07 | 225d |  |  |  | -0 | N/A | N/A | SIT | 5.4 | N/A | Systems Integration Testing (SIT) | -269.67 |  |  |  |  | SITAG |  |  |
| 917 | 1.4.1.4.2.8.1 | **Cycle 1 Test data (SIT A)** |  | 55d | 2023-12-18 A | 2024-03-01 A |  | 100% | 2023-12-18 | 2024-03-01 | 55d |  |  |  | -0 | N/A | N/A | SIT | 5.4 | N/A | Systems Integration Testing (SIT) | -269.67 |  |  |  |  |  |  |  |
| 918 | 1.4.1.4.2.8.1.1 | Prepare, Generate and Allocate Test Data |  | 28d | 2023-12-18 A | 2024-01-24 A | 647, 655 | 100% | 2023-12-18 | 2024-01-24 | 28d |  |  | start no earlier than 2023-12-11 |  | SI Test Data |  | SIT | 5.14 | Richard Puddephatt | Systems Integration Testing (SIT) |  | Complete | COMPLETE |  |  |  |  |  |
| 919 | 1.4.1.4.2.8.1.2 | Transmit Data Sets to PPs |  | 4d | 2024-01-26 A | 2024-01-31 A | 918FS+1d | 100% | 2024-01-26 | 2024-01-31 | 2d |  |  |  |  | SI Test Data |  | SIT | 5.14 | Richard Puddephatt | Systems Integration Testing (SIT) |  | Complete | COMPLETE |  |  |  |  |  |
| 920 | 1.4.1.4.2.8.1.3 | PP's Iterative load and data integrity check |  | 22d | 2024-02-01 A | 2024-03-01 A | 919 | 100% | 2024-02-01 | 2024-03-01 | 10d |  |  |  |  | PP |  | SIT | 5.14 | Richard Puddephatt | Systems Integration Testing (SIT) |  | Complete | COMPLETE |  |  |  |  |  |
| 921 | 1.4.1.4.2.8.1.4 | Cycle 1 - PP's confirmation that test data is ready for SIT Functional | milestone | 0d | 2024-03-01 A | 2024-03-01 A | 920 | 100% | 2024-03-01 | 2024-03-01 | 0d |  |  |  |  | SI Test Data |  | SIT | 5.18 | Richard Puddephatt | Systems Integration Testing (SIT) |  | Complete | COMPLETE | 2/8 - added as a T3 milestone. Awaiting approval at TMAG | T3-TE-0079 | SITAG | T3 | MHHS-ART140 MHHS-ART169 |
| 922 | 1.4.1.4.2.8.2 | **Cycle 2 Test data (inc. Settlement Data) (SIT A)** |  | 57d | 2024-03-28 A | 2024-06-14 A |  | 100% | 2024-03-28 | 2024-06-14 | 47d |  |  |  | -0 | N/A | N/A | SIT | 6.0 | N/A | Systems Integration Testing (SIT) |  |  |  |  |  |  |  |  |
| 923 | 1.4.1.4.2.8.2.1 | Prepare, Generate and Allocate Test Data |  | 31d | 2024-03-28 A | 2024-05-09 A | 921FS+18d | 100% | 2024-03-28 | 2024-05-09 | 31d |  |  |  |  | SI Test Data |  | SIT | 5.14 | Richard Puddephatt | Systems Integration Testing (SIT) |  | Complete | COMPLETE |  |  |  |  |  |
| 924 | 1.4.1.4.2.8.2.2 | Transmit Data Sets to PPs |  | 3d | 2024-05-10 A | 2024-05-14 A | 923 | 100% | 2024-05-10 | 2024-05-14 | 3d |  |  |  |  | SI Test Data |  | SIT | 5.14 | Richard Puddephatt | Systems Integration Testing (SIT) |  | Complete | COMPLETE |  |  |  |  |  |
| 925 | 1.4.1.4.2.8.2.3 | PP's Iterative load and data integrity check |  | 13d | 2024-05-15 A | 2024-05-31 A | 924 | 100% | 2024-05-15 | 2024-05-31 | 13d |  |  |  |  | PP |  | SIT | 5.14 | Richard Puddephatt | Systems Integration Testing (SIT) |  | Complete | COMPLETE |  |  |  |  |  |
| 926 | 1.4.1.4.2.8.2.4 | Cycle 2 - PP's confirmation that test data is ready for SIT Functional | milestone | 0d | 2024-06-14 A | 2024-06-14 A | 925FS+10d | 100% | 2024-06-14 | 2024-06-14 | 0d |  |  |  |  | SI Test Data |  | SIT | 5.27 | Richard Puddephatt | Systems Integration Testing (SIT) |  | Complete | COMPLETE | 2/8 - added as a T3 milestone. Awaiting approval at TMAG | T3-TE-0080 | SITAG | T3 | MHHS-ART140 MHHS-ART169 |

| ID | WBS | Task | Duration | Start | Finish | Predecessors | Complete | Baseline start | Baseline finish | Baseline duration | Baseline 1 start | Baseline 1 finish | Constraint | Baseline cost | Responsible | Involved | Text9 | Update Version | Sched Status | MHHS Resource Name | MHHS Programme Phase | Text29 | RAG | Milestone ID |
| --- | --- | --- | --- | --- | --- | --- | --- | --- | --- | --- | --- | --- | --- | --- | --- | --- | --- | --- | --- | --- | --- | --- | --- | --- |
| 927 | 1.4.1.4.2.8.3 | **Cycle 3 Test data (SIT A) (2)** | 71d? | 2024-07-15 A | 2024-10-21 A |  | 100% | 2024-07-15 | 2024-10-21 | 41d |  |  |  | -0 | N/A | N/A | SIT | 5.4 | Overdue | N/A | Systems Integration Testing (SIT) | SITAG |  |  |
| 928 | 1.4.1.4.2.8.3.1 | Cycle 3 data requirments analysis - check Cycle 2 data for gaps Check blocked test cases | 10d? | 2024-07-15 A | 2024-07-26 A |  | 100% | 2024-07-15 | 2024-07-26 | 0d |  |  | finish no earlier than 2024-07-26 |  |  |  | SIT | 6.0 | Complete | Richard Puddephatt |  | SITAG | COMPLETE |  |
| 929 | 1.4.1.4.2.8.3.2 | Provide DCC with MPANS for deletion secure file with password | 1d? | 2024-08-12 A | 2024-08-12 A |  | 100% | 2024-08-12 | 2024-08-12 | 0d |  |  |  |  |  |  | SIT | 6.0 | Complete | Richard Puddephatt |  |  | COMPLETE |  |
| 930 | 1.4.1.4.2.8.3.3 | Receive MPANS from DCC to exclude | 1d? | 2024-08-09 A | 2024-08-09 A |  | 100% | 2024-08-09 | 2024-08-09 | 0d |  |  |  |  |  |  | SIT | 6.0 | Complete | Richard Puddephatt |  |  | COMPLETE |  |
| 931 | 1.4.1.4.2.8.3.4 | Exclude MPANS from allocation | 1d | 2024-08-16 A | 2024-08-16 A |  | 100% | 2024-08-16 | 2024-08-16 | 0d |  |  |  |  |  |  | SIT | 6.0 | Complete | Richard Puddephatt |  |  | COMPLETE |  |
| 932 | 1.4.1.4.2.8.3.5 | Allocate Cycle 3 MPANS | 16d? | 2024-08-06 A | 2024-08-27 A |  | 100% | 2024-08-06 | 2024-08-27 | 0d |  |  |  |  |  |  | SIT | 6.0 | Complete | Richard Puddephatt |  |  | COMPLETE |  |
| 933 | 1.4.1.4.2.8.3.6 | Generate Cycle 3 Data | 2d? | 2024-08-27 A | 2024-08-28 A |  | 100% | 2024-08-27 | 2024-08-28 | 0d |  |  |  |  |  |  | SIT | 6.0 | Complete | Richard Puddephatt |  |  | COMPLETE |  |
| 934 | 1.4.1.4.2.8.3.7 | Check data prior to sending to DCC | 5d? | 2024-08-22 A | 2024-08-28 A |  | 100% | 2024-08-22 | 2024-08-28 | 0d |  |  |  |  |  |  | SIT | 6.0 | Complete | Richard Puddephatt |  |  | COMPLETE |  |
| 935 | 1.4.1.4.2.8.3.8 | Share Cycle 3 MPAN data with DCC | 1d? | 2024-08-29 A | 2024-08-29 A |  | 100% | 2024-08-29 | 2024-08-29 | 0d |  |  |  |  |  |  | SIT | 6.0 | Complete | Richard Puddephatt |  |  | COMPLETE |  |
| 936 | 1.4.1.4.2.8.3.9 | DCC - load data and create registration Id's for Cycle 3 data | 13d? | 2024-08-27 A | 2024-09-12 A |  | 100% | 2024-08-27 | 2024-09-12 | 0d |  |  |  |  |  |  | SIT | 6.0 | Complete | Richard Puddephatt |  |  | COMPLETE |  |
| 937 | 1.4.1.4.2.8.3.10 | Add registration ID's to Cycle 3 Data | 2d? | 2024-09-12 A | 2024-09-13 A |  | 100% | 2024-09-12 | 2024-09-13 | 0d |  |  |  |  |  |  | SIT | 6.0 | Complete | Richard Puddephatt |  |  | COMPLETE |  |
| 938 | 1.4.1.4.2.8.3.11 | Share subset of data with St Cls for data load | 2d? | 2024-09-12 A | 2024-09-13 A |  | 100% | 2024-09-12 | 2024-09-13 | 0d |  |  |  |  |  |  | SIT | 6.0 | Complete | Richard Puddephatt |  |  | COMPLETE |  |
| 939 | 1.4.1.4.2.8.3.12 | St Clements to run test with Subset of data - MPRS business process checks including Import/Export MPANS | 5d? | 2024-09-16 A | 2024-09-20 A |  | 100% | 2024-09-16 | 2024-09-20 | 0d |  |  |  |  |  |  | SIT | 6.0 | Complete | Richard Puddephatt |  |  | COMPLETE |  |
| 940 | 1.4.1.4.2.8.3.13 | Send Cycle 3 data to partcipants for early sight of data | 3d? | 2024-09-25 A | 2024-09-27 A |  | 100% | 2024-09-25 | 2024-09-27 | 0d |  |  |  |  |  |  | SIT | 6.0 | Complete | Richard Puddephatt |  |  | COMPLETE |  |
| 941 | 1.4.1.4.2.8.3.14 | St Clements MPRS data load bulk files for Cycle 3 | 15d? | 2024-09-23 A | 2024-10-11 A |  | 100% | 2024-09-23 | 2024-10-11 | 0d |  |  |  |  |  |  | SIT | 6.0 | Complete | Richard Puddephatt |  |  | COMPLETE |  |
| 942 | 1.4.1.4.2.8.3.15 | New MPAN creation and load through DCC and St Clements | 1d? | 2024-10-11 A | 2024-10-11 A |  | 100% | 2024-10-11 | 2024-10-11 | 0d |  |  | start no earlier than 2024-10-11 |  |  |  | SIT | 6.0 | Complete | Richard Puddephatt |  |  | COMPLETE |  |
| 943 | 1.4.1.4.2.8.3.16 | Share files with PP's and central parties | 1d | 2024-10-11 A | 2024-10-11 A |  | 100% | 2024-10-11 | 2024-10-11 | 0d |  |  | start no earlier than 2024-10-11 |  |  |  | SIT | 6.0 | Complete | Richard Puddephatt |  |  | COMPLETE |  |
| 944 | 1.4.1.4.2.8.3.17 | Avanade to load data | 6d | 2024-10-14 A | 2024-10-21 A |  | 100% | 2024-10-14 | 2024-10-21 | 0d |  |  | start no earlier than 2024-10-14 |  |  |  | SIT | 6.0 | Complete | Richard Puddephatt |  |  | COMPLETE |  |
| 945 | 1.4.1.4.2.8.3.18 | Helix to load data | 6d | 2024-10-14 A | 2024-10-21 A |  | 100% | 2024-10-14 | 2024-10-21 | 0d |  |  | start no earlier than 2024-10-14 |  |  |  | SIT | 6.0 | Complete | Richard Puddephatt |  |  | COMPLETE |  |
| 946 | 1.4.1.4.2.8.3.19 | PP's and central parties to load all Cycle 3 data | 6d | 2024-10-14 A | 2024-10-21 A |  | 100% | 2024-10-14 | 2024-10-21 | 0d |  |  | start no earlier than 2024-10-14 |  |  |  | SIT | 6.0 | Complete | Richard Puddephatt |  |  | COMPLETE |  |
| 947 | 1.4.1.4.2.8.3.20 | All parties to finalise data load | 1d? | 2024-10-21 A | 2024-10-21 A |  | 100% | 2024-10-21 | 2024-10-21 | 0d |  |  | start no earlier than 2024-10-21 |  | SI Data |  | SIT | 6.0 | Complete | Richard Puddephatt |  | SITAG | COMPLETE | T3-TE-0081 |
| 948 | 1.4.1.4.2.9 | **SIT Functional Test Readiness Report** | 45d | 2024-01-01 A | 2024-03-01 A |  | 100% | 2024-01-01 | 2024-03-01 | 44d | 2024-01-01 | 2024-02-23 |  | -0 | N/A | N/A | SIT | 5.0 |  | N/A | Systems Integration Testing (SIT) |  |  |  |
| 949 | 1.4.1.4.2.9.1 | **PP SIT Functional Test Readiness Report** | 44d | 2024-01-01 A | 2024-02-29 A |  | 100% | 2024-01-01 | 2024-02-29 | 44d | 2024-01-01 | 2024-02-09 |  | -0 | N/A | N/A | SIT | 5.0 |  | N/A | Systems Integration Testing (SIT) |  |  |  |
| 950 | 1.4.1.4.2.9.1.1 | Develop draft Test Readiness Report and submit to Programme for assurance | 21d | 2024-01-01 A | 2024-01-29 A |  | 100% | 2024-01-01 | 2024-01-29 | 20d | 2024-01-01 | 2024-01-29 | start no earlier than 2024-01-01 |  | PP | SI Test | SIT | 5.0 | Complete |  | Systems Integration Testing (SIT) |  | COMPLETE |  |
| 951 | 1.4.1.4.2.9.1.2 | Placing Reliance Stage 2 Review | 34d | 2024-01-15 A | 2024-02-29 A | 950SS+10d | 100% | 2024-01-15 | 2024-02-29 | 34d |  |  |  |  | SI Test | PP | SIT | 5.12 | Complete |  | Systems Integration Testing (SIT) |  | COMPLETE |  |
| 952 | 1.4.1.4.2.9.1.3 | Finalise Test Readiness Report and submit to Programme for assurance | 9d | 2024-01-30 A | 2024-02-09 A | 950 | 100% | 2024-01-30 | 2024-02-09 | 10d | 2024-01-29 | 2024-02-09 |  |  | PP | SI Test | SIT | 5.0 | Complete |  | Systems Integration Testing (SIT) |  | COMPLETE |  |

| ID | WBS | Task | Type | Duration | Start | Finish | Predecessors | Complete | Remaining | Baseline start | Baseline finish | Baseline duration | Baseline 1 start | Baseline 1 finish | Total slack | Constraint | Baseline cost | Responsible | Involved | Text9 | Update Version | MHHS Resource Name | MHHS Programme Phase | Sched Status | RAG | Milestone ID | Text29 | Tier | Artefact ID | Task Status |
| --- | --- | --- | --- | --- | --- | --- | --- | --- | --- | --- | --- | --- | --- | --- | --- | --- | --- | --- | --- | --- | --- | --- | --- | --- | --- | --- | --- | --- | --- | --- |
| 953 | 1.4.1.4.2.9.2 | **SI SIT Functional Test Readiness Report** |  | 40d | 2024-01-01 A | 2024-02-23 A |  | 100% |  | 2024-01-01 | 2024-02-23 | 40d | 2024-01-01 | 2024-02-23 |  |  |  | N/A | N/A | SIT | 5.0 | N/A | Systems Integration Testing (SIT) |  |  |  |  |  |  |  |
| 954 | 1.4.1.4.2.9.2.1 | Assure Test Participants' Test Readiness Reports |  | 35d | 2024-01-01 A | 2024-02-16 A | 950SS, 952FF+5d | 100% |  | 2024-01-01 | 2024-02-16 | 35d | 2024-01-01 | 2024-02-16 |  |  |  | SI Test | PP,IPA | SIT | 5.0 |  | Systems Integration Testing (SIT) | Complete | COMPLETE |  |  |  |  |  |
| 955 | 1.4.1.4.2.9.2.2 | Develop Overarching SIT Functional Test Readiness Report |  | 20d | 2024-01-22 A | 2024-02-16 A | 954FF | 100% |  | 2024-01-22 | 2024-02-16 | 20d | 2024-01-22 | 2024-02-16 |  |  |  | SI Test |  | SIT | 5.0 |  | Systems Integration Testing (SIT) | Complete | COMPLETE |  |  |  |  |  |
| 956 | 1.4.1.4.2.9.2.3 | Artefact review (via TMAG) and updates |  | 5d | 2024-02-19 A | 2024-02-23 A | 955 | 100% |  | 2024-02-19 | 2024-02-23 | 5d | 2024-02-19 | 2024-02-23 |  |  |  | SI Test | PP,IPA | SIT | 5.0 |  | Systems Integration Testing (SIT) | Complete | COMPLETE |  |  |  |  |  |
| 957 | 1.4.1.4.2.9.3 | SIT Functional Testing Preparation Complete | milestone | 0d | 2024-03-01 A | 2024-03-01 A | 956FF+5d, 834, 355, 951, 842, 849, 921 | 100% |  | 2024-03-01 | 2024-03-01 | 0d | 2024-03-01 | 2024-03-01 |  |  |  | SI Test | PP,IPA | SIT | 5.0 |  | Systems Integration Testing (SIT) | Complete | COMPLETE | T2-TE-0550 | SITAG | T2 |  |  |
| 958 | 1.4.1.4.3 | **SIT Migration Testing Preparation** |  | 560d? | 2022-10-31 A | 2024-12-20 |  | 94% | 32.67d? | 2022-10-31 | 2024-10-04 | 420d | 2022-11-16 | 2024-06-03 | 784d |  | -0 | N/A | N/A | SIT | 5.21 | N/A | Systems Integration Testing (SIT) |  |  |  |  |  |  |  |
| 959 | 1.4.1.4.3.1 | **Test Approach & Plan** |  | 75d | 2023-09-07 A | 2023-12-20 A |  | 100% |  | 2023-09-07 | 2023-12-20 | 75d | 2023-09-07 | 2023-12-20 |  |  | -0 | N/A | N/A | SIT | 5.0 |  | Systems Integration Testing (SIT) |  |  |  |  |  |  |  |
| 960 | 1.4.1.4.3.1.1 | Develop document with SITWG |  | 32d | 2023-09-07 A | 2023-10-20 A | 2438 | 100% |  | 2023-09-07 | 2023-10-20 | 25d | 2023-09-07 | 2023-10-11 |  | finish no earlier than 2023-10-11 |  | SI Test |  | SIT | 5.0 |  | Systems Integration Testing (SIT) | Complete | COMPLETE |  |  |  |  |  |
| 961 | 1.4.1.4.3.1.2 | Draft document review with Code Bodies |  | 8d | 2023-10-23 A | 2023-11-01 A | 960 | 100% |  | 2023-10-23 | 2023-11-01 | 10d | 2023-10-12 | 2023-10-25 |  |  |  | SI Test | Code Bodies | SIT | 5.0 |  | Systems Integration Testing (SIT) | Complete | COMPLETE |  |  |  |  |  |
| 962 | 1.4.1.4.3.1.3 | Industry Consultation |  | 10d | 2023-11-02 A | 2023-11-15 A | 961 | 100% |  | 2023-11-02 | 2023-11-15 | 10d |  |  |  |  |  | PP |  | SIT | 5.1 |  | Systems Integration Testing (SIT) | Complete | COMPLETE |  |  |  |  |  |
| 963 | 1.4.1.4.3.1.4 | Artefact review (via TMAG) and updates |  | 25d | 2023-11-16 A | 2023-12-20 A | 962 | 100% |  | 2023-11-16 | 2023-12-20 | 30d | 2023-10-26 | 2023-12-20 |  |  |  | SI Test | PP,IPA,Code Bodies | SIT | 5.0 |  | Systems Integration Testing (SIT) | Complete | COMPLETE |  |  |  |  |  |
| 964 | 1.4.1.4.3.1.5 | SIT Migration Testing Test Approach & Plan approved | milestone | 0d | 2023-12-20 A | 2023-12-20 A | 963 | 100% |  | 2023-12-20 | 2023-12-20 | 1d | 2023-12-20 | 2023-12-20 |  | finish no earlier than 2023-12-20 |  | SI Test | PP | SIT | 5.14 |  | Systems Integration Testing (SIT) | Complete | COMPLETE | T3-TE-0018 | SITAG | T3 | MHHS-ART073 |  |
| 965 | 1.4.1.4.3.2 | **Test Data Approach & Plan** |  | 35d | 2023-11-02 A | 2023-12-20 A |  | 100% |  | 2023-11-02 | 2023-12-20 | 35d | 2023-10-26 | 2023-12-20 |  |  | -0 | N/A | N/A | SIT | 5.0 | N/A | Systems Integration Testing (SIT) |  |  |  |  |  |  |  |
| 966 | 1.4.1.4.3.2.1 | Industry Consultation |  | 10d | 2023-11-02 A | 2023-11-15 A | 962SS | 100% |  | 2023-11-02 | 2023-11-15 | 10d |  |  |  |  |  | PP |  | SIT | 5.1 | PP | Systems Integration Testing (SIT) | Complete | COMPLETE |  |  |  |  |  |
| 967 | 1.4.1.4.3.2.2 | Artefact review (via TMAG) and updates |  | 25d | 2023-11-16 A | 2023-12-20 A | 966 | 100% |  | 2023-11-16 | 2023-12-20 | 30d | 2023-10-26 | 2023-12-20 |  |  |  | SI Test Data |  | SIT | 5.0 | Richard Puddephatt | Systems Integration Testing (SIT) | Complete | COMPLETE |  |  |  |  |  |
| 968 | 1.4.1.4.3.2.3 | SIT Migration Test Data Test Approach & Plan approved | milestone | 0d | 2023-12-20 A | 2023-12-20 A | 967 | 100% |  | 2023-12-20 | 2023-12-20 | 0d | 2023-12-20 | 2023-12-20 |  |  |  | SI Test Data | PP,IPA | SIT | 5.14 | Richard Puddephatt | Systems Integration Testing (SIT) | Complete | COMPLETE |  |  |  |  |  |
| 969 | 1.4.1.4.3.3 | **Test scenarios & Test Cases** |  | 262d? | 2023-12-21 A | 2024-12-20 |  | 81% | 50.91d? | 2023-12-21 | 2024-10-04 | 65d | 2023-07-24 | 2024-01-17 | 784d |  | -0 | N/A | N/A | SIT | 5.16 | N/A | Systems Integration Testing (SIT) |  |  |  |  |  |  |  |
| 970 | 1.4.1.4.3.3.1 | **Theme 1** |  | 65d | 2023-12-21 A | 2024-03-20 A |  | 100% |  | 2023-12-21 | 2024-03-20 | 65d |  |  |  |  | -0 | N/A | N/A | SIT | 5.16 | N/A | Systems Integration Testing (SIT) |  |  |  |  |  |  | -448.67 |
| 971 | 1.4.1.4.3.3.1.1 | Develop Test Scenarios & Test Cases |  | 25d | 2023-12-21 A | 2024-01-24 A | 964 | 100% |  | 2023-12-21 | 2024-01-24 | 25d |  |  |  |  |  | SI Test | SI Test, PP | SIT | 5.16 |  |  | Complete | COMPLETE |  |  |  |  |  |
| 972 | 1.4.1.4.3.3.1.2 | Industry Review Workshop |  | 1d | 2024-01-25 A | 2024-01-25 A | 971 | 100% |  | 2024-01-25 | 2024-01-25 | 1d |  |  |  |  |  | SI Test, PP | SI Test, PP | SIT | 5.16 |  |  | Complete | COMPLETE |  |  |  |  |  |
| 973 | 1.4.1.4.3.3.1.3 | Industry Consultation Review |  | 6d | 2024-02-05 A | 2024-02-12 A | 972FS+6d | 100% |  | 2024-02-05 | 2024-02-12 | 6d |  |  |  |  |  | SI Test, PP | SI Test, PP | SIT | 5.16 |  |  | Complete | COMPLETE |  |  |  |  |  |
| 974 | 1.4.1.4.3.3.1.4 | Review with SIT Working Group |  | 5d | 2024-02-29 A | 2024-03-06 A | 973FS+12d | 100% |  | 2024-02-29 | 2024-03-06 | 5d |  |  |  |  |  | SI Test, PP | SI Test, PP | SIT | 5.19 |  |  | Complete | COMPLETE |  |  |  |  |  |
| 975 | 1.4.1.4.3.3.1.5 | SIT Migration Test scenarios & Test Cases Approved - Theme 1 | milestone | 0d | 2024-03-20 A | 2024-03-20 A | 974FS+10d | 100% |  | 2024-03-20 | 2024-03-20 | 0d |  |  |  |  |  | SI Test | SI Test, PP | SIT | 5.21 |  | Systems Integration Testing (SIT) | Complete | COMPLETE | T3-TE-0110 | SITAG |  |  |  |
| 976 | 1.4.1.4.3.3.2 | **Theme 2** |  | 85d | 2023-12-21 A | 2024-04-17 A |  | 100% |  | 2023-12-21 | 2024-04-17 | 85d |  |  |  |  | -0 | N/A | N/A | SIT | 5.16 | N/A | Systems Integration Testing (SIT) |  |  |  |  |  |  | -448.67 |
| 977 | 1.4.1.4.3.3.2.1 | Develop Test Scenarios & Test Cases |  | 40d | 2023-12-21 A | 2024-02-14 A | 964 | 100% |  | 2023-12-21 | 2024-02-14 | 40d |  |  |  |  |  | SI Test | SI Test, PP | SIT | 5.16 |  |  | Complete | COMPLETE |  |  |  |  |  |
| 978 | 1.4.1.4.3.3.2.2 | Industry Review Workshop |  | 1d | 2024-02-15 A | 2024-02-15 A | 977 | 100% |  | 2024-02-15 | 2024-02-15 | 1d |  |  |  |  |  | SI Test, PP | SI Test, PP | SIT | 5.16 |  |  | Complete | COMPLETE |  |  |  |  |  |
| 979 | 1.4.1.4.3.3.2.3 | Industry Consultation Review |  | 6d | 2024-02-26 A | 2024-03-04 A | 978FS+6d | 100% |  | 2024-02-26 | 2024-03-04 | 6d |  |  |  |  |  | SI Test, PP | SI Test, PP | SIT | 5.19 |  |  | Complete | COMPLETE |  |  |  |  |  |
| 980 | 1.4.1.4.3.3.2.4 | Review with SIT Working Group |  | 5d | 2024-03-28 A | 2024-04-03 A | 979FS+17d | 100% |  | 2024-03-28 | 2024-04-03 | 5d |  |  |  |  |  | SI Test, PP | SI Test, PP | SIT | 5.16 |  |  | Complete | COMPLETE |  |  |  |  |  |
| 981 | 1.4.1.4.3.3.2.5 | SIT Migration Test scenarios & Test Cases Approved - Theme 2 | milestone | 0d | 2024-04-17 A | 2024-04-17 A | 980FS+10d | 100% |  | 2024-04-17 | 2024-04-17 | 0d |  |  |  |  |  | SI Test | SI Test, PP | SIT | 5.22 |  | Systems Integration Testing (SIT) | Complete | COMPLETE | T3-TE-0111 | SITAG |  |  |  |

| ID | WBS | Task | Type | Duration | Start | Finish | Predecessors | Complete | Remaining | Baseline start | Baseline finish | Baseline duration | Total slack | Free slack | Constraint | Baseline cost | Responsible | Involved | Text9 | Task Status | Update Version | MHHS Resource Name | MHHS Programme Phase | Sched Status | RAG | Milestone ID | Text29 |
| --- | --- | --- | --- | --- | --- | --- | --- | --- | --- | --- | --- | --- | --- | --- | --- | --- | --- | --- | --- | --- | --- | --- | --- | --- | --- | --- | --- |
| 982 | 1.4.1.4.3.3.3 | **Theme 3** |  | 85d | 2023-12-21 A | 2024-04-17 A |  | 100% |  | 2023-12-21 | 2024-04-17 | 85d |  |  |  | -0 | N/A | N/A | SIT | -448.67 | 5.16 | N/A | Systems Integration Testing (SIT) |  |  |  |  |
| 983 | 1.4.1.4.3.3.3.1 | Develop Test Scenarios & Test Cases |  | 55d | 2023-12-21 A | 2024-03-06 A | 964 | 100% |  | 2023-12-21 | 2024-03-06 | 55d |  |  |  |  | SI Test | SI Test, PP | SIT |  | 5.19 |  |  | Complete | COMPLETE |  |  |
| 984 | 1.4.1.4.3.3.3.2 | Industry Review Workshop |  | 1d | 2024-03-07 A | 2024-03-07 A | 983 | 100% |  | 2024-03-07 | 2024-03-07 | 1d |  |  |  |  | SI Test, PP | SI Test, PP | SIT |  | 5.16 |  |  | Complete | COMPLETE |  |  |
| 985 | 1.4.1.4.3.3.3.3 | Industry Consultation Review |  | 6d | 2024-03-13 A | 2024-03-20 A | 984FS+3d | 100% |  | 2024-03-13 | 2024-03-20 | 6d |  |  |  |  | SI Test, PP | SI Test, PP | SIT |  | 5.16 |  |  | Complete | COMPLETE |  |  |
| 986 | 1.4.1.4.3.3.3.4 | Review with SIT Working Group |  | 5d | 2024-03-28 A | 2024-04-03 A | 985FS+5d | 100% |  | 2024-03-28 | 2024-04-03 | 5d |  |  |  |  | SI Test, PP | SI Test, PP | SIT |  | 5.16 |  |  | Complete | COMPLETE |  |  |
| 987 | 1.4.1.4.3.3.3.5 | SIT Migration Test scenarios & Test Cases Approved - Theme 3 | milestone | 0d | 2024-04-17 A | 2024-04-17 A | 986FS+10d | 100% |  | 2024-04-17 | 2024-04-17 | 0d |  |  |  |  | SI Test | SI Test, PP | SIT |  | 5.22 |  | Systems Integration Testing (SIT) | Complete | COMPLETE | T3-TE-0112 | SITAG |
| 988 | 1.4.1.4.3.3.4 | **RTTM Development** |  | 27d? | 2024-08-29 A | 2024-10-04 |  | 84% | 4.38d? | 2024-08-29 | 2024-10-04 | 0d | 839d |  |  |  | SI Test |  | SIT | -693.67 | 6.0 | Ankur Pande |  | Overdue Start | GREEN |  |  |
| 989 | 1.4.1.4.3.3.4.1 | Develop Manual SIT Migration RTTM |  | 17d | 2024-08-29 A | 2024-09-20 A |  | 100% |  | 2024-08-29 | 2024-09-20 | 0d |  |  | start no earlier than 2024-08-29 |  | SI Test |  | SIT |  | 6.0 | Ankur Pande |  | Complete | COMPLETE |  |  |
| 990 | 1.4.1.4.3.3.4.2 | Manual SIT Migration RTTM Complete | milestone | 0d | 2024-09-20 A | 2024-09-20 A | 989 | 100% |  | 2024-09-20 | 2024-09-20 | 0d |  |  |  |  | SI Test |  | SIT |  | 6.0 | Ankur Pande |  | Complete | COMPLETE |  |  |
| 991 | 1.4.1.4.3.3.4.3 | Develop Automated SIT Migration RTTM |  | 20d | 2024-09-09 A | 2024-10-04 |  | 70% | 6d | 2024-09-09 | 2024-10-04 | 0d | 839d | 0d | start no earlier than 2024-09-09 |  | SI Test |  | SIT |  | 6.0 | Ankur Pande |  | Overdue | RED |  |  |
| 992 | 1.4.1.4.3.3.4.4 | Automated SIT Migration RTTM Complete | milestone | 0d? | 2024-10-04 | 2024-10-04 | 991 |  |  | 2024-10-04 | 2024-10-04 | 0d | 839d |  |  |  | SI Test |  | SIT | -53.29 | 6.0 | Ankur Pande |  | Overdue Start | RED |  |  |
| 993 | 1.4.1.4.3.3.5 | **Gap analysis** |  | 72d? | 2024-09-12 A | 2024-12-20 |  | 51% | 35.39d? | 2024-09-12 | 2024-10-04 | 0d | 784d |  |  |  | SI Test |  | SIT | -693.67 | 6.0 | Ankur Pande |  | Overdue Start | GREEN |  |  |
| 994 | 1.4.1.4.3.3.5.1 | Identify gaps in test case coverage following RTTM review. |  | 12d | 2024-09-12 A | 2024-09-27 A | 989SS+10d | 100% |  | 2024-09-12 | 2024-09-27 | 0d |  |  |  |  | SI Test |  | SIT |  | 6.0 | Ankur Pande |  | Complete | COMPLETE |  |  |
| 995 | 1.4.1.4.3.3.5.2 | Address gaps in test case coverage following RTTM review. |  | 17d | 2024-09-19 A | 2024-10-11 | 994SS+5d | 14% | 14.6d | 2024-09-19 | 2024-10-04 | 0d | 834d |  |  |  | SI Test |  | SIT |  | 6.0 | Ankur Pande |  | Overdue | RED |  |  |
| 996 | 1.4.1.4.3.3.5.3 | Gap analysis complete | milestone | 0d? | 2024-10-11 A | 2024-10-11 A | 995 | 100% |  | 2024-10-04 | 2024-10-04 | 0d |  |  |  |  | SI Test |  | SIT |  | 6.0 | Ankur Pande |  | Complete | COMPLETE |  |  |
| 997 | 1.4.1.4.3.3.5.4 | Test Script updates identified |  | 1d? | 2024-10-14 A | 2024-10-14 A | 996 | 100% |  | 2024-10-14 | 2024-10-14 | 0d |  |  |  |  | SI Test |  | SIT |  | 6.11 | Ankur Pande |  | Complete | COMPLETE |  |  |
| 998 | 1.4.1.4.3.3.5.5 | Test Scripts updates |  | 16d? | 2024-10-14 A | 2024-11-04 A | 997FS-1d | 100% |  | 2024-10-14 | 2024-11-04 | 0d |  |  |  |  | SI Test |  | SIT |  | 6.11 | Ankur Pande |  | Complete | COMPLETE |  |  |
| 999 | 1.4.1.4.3.3.5.6 | RTTM Updated |  | 1d? | 2024-10-29 A | 2024-10-29 A | 998FS-5d | 100% |  | 2024-10-29 | 2024-10-29 | 0d |  |  |  |  | SI Test |  | SIT |  | 6.11 | Ankur Pande |  | Complete | COMPLETE |  |  |
| 1000 | 1.4.1.4.3.3.5.7 | Removal of de-scoped TCs from the RTTMs |  | 2d | 2024-10-31 A | 2024-11-01 A | 998FS-3d | 100% |  | 2024-10-31 | 2024-11-01 | 0d |  |  |  |  | SI Test |  | SIT |  | 6.11 | Ankur Pande |  | Complete | COMPLETE |  |  |
| 1001 | 1.4.1.4.3.3.5.8 | Update and stabilisation of all TC ADO IDs |  | 2d | 2024-10-31 A | 2024-11-01 A | 998FS-3d | 100% |  | 2024-10-31 | 2024-11-01 | 0d |  |  |  |  | SI Test |  | SIT |  | 6.11 | Ankur Pande |  | Complete | COMPLETE |  |  |
| 1002 | 1.4.1.4.3.3.5.9 | Addition and integration of Role tags to reqs in the Role RTTMs |  | 3d | 2024-10-30 A | 2024-11-01 A | 998FS-4d | 100% |  | 2024-10-30 | 2024-11-01 | 0d |  |  |  |  | SI Test |  | SIT |  | 6.11 | Ankur Pande |  | Complete | COMPLETE |  |  |
| 1003 | 1.4.1.4.3.3.5.10 | Update of the RTTM All sheet (porting of the individual RTTMs) |  | 2d | 2024-10-31 A | 2024-11-01 A | 998FS-3d | 100% |  | 2024-10-31 | 2024-11-01 | 0d |  |  |  |  | SI Test |  | SIT |  | 6.11 | Ankur Pande |  | Complete | COMPLETE |  |  |
| 1004 | 1.4.1.4.3.3.5.11 | ADO IDs corrected |  | 1d? | 2024-11-04 A | 2024-11-04 A | 1003 | 100% |  | 2024-11-04 | 2024-11-04 | 0d |  |  | start no earlier than 2024-10-16 |  | SI Test |  | SIT |  | 6.11 | Ankur Pande |  | Complete | COMPLETE |  |  |
| 1005 | 1.4.1.4.3.3.5.12 | Migration RTTM ready for import into ADO | milestone | 0d | 2024-11-04 A | 2024-11-04 A | 1004 | 100% |  | 2024-11-04 | 2024-11-04 | 0d |  |  |  |  | SI Test |  | SIT |  | 6.11 | Ankur Pande |  | Complete | COMPLETE |  |  |
| 1006 | 1.4.1.4.3.3.5.13 | Issue Static RTTM to Code Bodies |  | 1d? | 2024-11-05 A | 2024-11-05 A | 1005 | 100% |  | 2024-11-05 | 2024-11-05 | 0d |  |  |  |  | SI Test |  | SIT |  | 6.11 | Ankur Pande |  | Complete | COMPLETE |  |  |
| 1007 | 1.4.1.4.3.3.5.14 | Implement Code Bodies feedback on RTTM |  | 6d | 2024-11-06 A | 2024-11-13 | 1006 | 80% | 1.2d | 2024-11-06 | 2024-11-13 | 0d | 784d | 0d |  |  | SI Test |  | SIT |  | 6.12 | Ankur Pande |  | Green | RED |  |  |
| 1008 | 1.4.1.4.3.3.5.15 | Code Body Acceptance of RTTM | milestone | 0d | 2024-11-13 A | 2024-11-13 | 1006, 1007 | 75% | 0d | 2024-11-06 | 2024-11-13 | 0d | 784d | 0d |  |  | SI Test |  | SIT |  | 6.11 | Ankur Pande |  | Green | RED |  |  |

Notes:
- 995: 11/11/24 - Session with Code Bodies on 12/11/24 to address outstanding RTTM gaps.
- 1007: 25/11/24 - Additional feedback round with Code Bodies required before this can be completed, which is in progress.
- 1008: 25/11/24 - Additional feedback round with Code Bodies required before this can be completed, which is in progress.

| ID | WBS | Task | Type | Duration | Start | Finish | Predecessors | Complete | Remaining | Actual start | Baseline start | Baseline finish | Total slack | Free slack | Constraint | Text9 | Task Status | Update Version | Sched Status | MHHS Resource Name | RAG | Milestone ID |
| --- | --- | --- | --- | --- | --- | --- | --- | --- | --- | --- | --- | --- | --- | --- | --- | --- | --- | --- | --- | --- | --- | --- |
| 1009 | 1.4.1.4.3.3.5.16 | **ADO Clean-up** |  | 17d? | 2024-10-24 | 2024-11-15 |  | 52% | 8.12d? | 2024-10-25 | 2024-10-24 | 2024-11-15 |  |  |  | SIT | -727.67 | 6.11 | Overdue Start | Heath Thomas |  |  |
| 1010 | 1.4.1.4.3.3.5.16.1 | Theme alignment |  | 1d? | 2024-10-28 A | 2024-10-28 |  | 90% | 0.1d? |  | 2024-10-28 | 2024-10-28 | 823d |  | start no earlier than 2024-10-28 | SIT |  | 6.11 | Green | Heath Thomas | RED |  |
| 1011 | 1.4.1.4.3.3.5.16.2 | Understand Additional suffix Fields in ADO as defined by Kevin |  | 1d? | 2024-10-25 | 2024-10-25 |  |  |  |  | 2024-10-25 | 2024-10-25 | 824d |  | finish no earlier than 2024-10-25 | SIT | -32.67 | 6.11 | Green | Heath Thomas | RED |  |
| 1012 | 1.4.1.4.3.3.5.16.3 | Correct Missing Test Case References |  | 1d? | 2024-10-28 | 2024-10-28 |  |  |  |  | 2024-10-28 | 2024-10-28 | 823d |  | start no earlier than 2024-10-28 | SIT | -29.67 | 6.11 | Green | Heath Thomas | RED |  |
| 1013 | 1.4.1.4.3.3.5.16.4 | Load Functional RTTMs into ADO |  | 1d? | 2024-10-28 A | 2024-10-28 A |  | 100% |  |  | 2024-10-28 | 2024-10-28 |  |  | start no earlier than 2024-10-28 | SIT |  | 6.11 | Complete | Heath Thomas | COMPLETE |  |
| 1014 | 1.4.1.4.3.3.5.16.5 | Load Migration RTTMs into ADO |  | 1d? | 2024-11-06 A | 2024-11-06 |  | 90% | 0.1d? |  | 2024-11-06 | 2024-11-06 | 816d |  | start no earlier than 2024-11-06 | SIT |  | 6.11 | Green | Heath Thomas | RED |  |
| 1015 | 1.4.1.4.3.3.5.16.6 | Confirm Missing fields in ADO are resolved |  | 1d? | 2024-11-07 | 2024-11-07 |  |  |  |  | 2024-11-07 | 2024-11-07 | 815d |  | finish no earlier than 2024-11-07 | SIT | -19.67 | 6.11 | Green | Heath Thomas | RED |  |
| 1016 | 1.4.1.4.3.3.5.16.7 | Reload Functional RTTM into ADO |  | 1d? | 2024-11-07 A | 2024-11-07 A |  | 100% |  |  | 2024-11-07 | 2024-11-07 |  |  | start no earlier than 2024-11-07 | SIT |  | 6.11 | Complete | Heath Thomas | COMPLETE |  |
| 1017 | 1.4.1.4.3.3.5.16.8 | **ADO Design Documentation** |  | 10d? | 2024-11-04 | 2024-11-15 |  | 45% | 5.5d? | 2024-11-15 | 2024-11-04 | 2024-11-15 |  |  |  | SIT | -727.67 | 6.11 | Overdue Start | Heath Thomas | RED |  |
| 1018 | 1.4.1.4.3.3.5.16.8.1 | Produce ADO high Level Design and Data Model |  | 1d? | 2024-11-15 A | 2024-11-15 |  | 90% | 0.1d? |  | 2024-11-15 | 2024-11-15 | 809d |  | finish no earlier than 2024-11-15 | SIT |  | 6.11 | Green | Heath Thomas | RED |  |
| 1019 | 1.4.1.4.3.3.5.16.8.2 | Produce Report derivation document |  | 1d? | 2024-11-15 | 2024-11-15 |  |  |  |  | 2024-11-15 | 2024-11-15 | 809d |  | finish no earlier than 2024-11-15 | SIT | -11.67 | 6.11 | Green | Heath Thomas | AMBER |  |
| 1020 | 1.4.1.4.3.3.5.17 | **Test Case Rationalisation (Fuctional + Migration)** |  | 32d | 2024-11-07 A | 2024-12-20 |  | 3% | 31.03d |  | 2024-11-07 | 2024-12-20 | 784d |  |  | SIT | -727.67 | 6.11 | Overdue Start | Roger Robar | RED |  |
| 1021 | 1.4.1.4.3.3.5.17.1 | Internal preliminary rationalisation workshop 1 |  | 1d | 2024-11-07 A | 2024-11-07 A | 1006FS+1d | 100% |  |  | 2024-11-07 | 2024-11-07 |  |  |  | SIT |  | 6.11 | Complete | Roger Robar | COMPLETE |  |
| 1022 | 1.4.1.4.3.3.5.17.2 | Baseline RTTMs | milestone | 0d | 2024-11-13 | 2024-11-13 | 1008 |  |  |  | 2024-11-13 | 2024-11-13 | 811d |  |  | SIT | -13.29 | 6.11 | Green | Roger Robar | RED |  |
| 1023 | 1.4.1.4.3.3.5.17.3 | Baseline test cases | milestone | 0d | 2024-11-13 | 2024-11-13 | 1008 |  |  |  | 2024-11-13 | 2024-11-13 | 784d | 0d |  | SIT | -13.29 | 6.11 | Green | Roger Robar | RED |  |
| 1024 | 1.4.1.4.3.3.5.17.4 | Produce requirements / test case analysis |  | 1d | 2024-11-14 | 2024-11-14 | 1023 |  |  |  | 2024-11-14 | 2024-11-14 | 784d | 0d |  | SIT | -12.67 | 6.11 | Green | Roger Robar | RED |  |
| 1025 | 1.4.1.4.3.3.5.17.5 | Internal finalisation rationalisation workshop 2 |  | 1d | 2024-11-15 | 2024-11-15 | 1024 |  |  |  | 2024-11-15 | 2024-11-15 | 784d | 0d |  | SIT | -11.67 | 6.11 | Green | Roger Robar | RED |  |
| 1026 | 1.4.1.4.3.3.5.17.6 | SRO walkthrough |  | 1d | 2024-11-21 | 2024-11-21 | 1025FS+3d |  |  |  | 2024-11-21 | 2024-11-21 | 784d | 0d |  | SIT | -5.67 | 6.11 | Green | Roger Robar | RED |  |
| 1027 | 1.4.1.4.3.3.5.17.7 | Code Bodies walkthrough |  | 1d | 2024-11-26 | 2024-11-26 | 1026FS+2d |  |  |  | 2024-11-26 | 2024-11-26 | 784d | 0d |  | SIT | -0.67 | 6.11 | Green | Roger Robar | RED |  |
| 1028 | 1.4.1.4.3.3.5.17.8 | Send invites to PPs for walkthrough |  | 1d | 2024-11-26 | 2024-11-26 | 1027FS-1d |  |  |  | 2024-11-26 | 2024-11-26 | 784d | 0d |  | SIT | -0.67 | 6.11 | Green | Roger Robar | RED |  |
| 1029 | 1.4.1.4.3.3.5.17.9 | PP walkthrough |  | 1d | 2024-12-03 | 2024-12-03 | 1028FS+4d |  |  |  | 2024-12-03 | 2024-12-03 | 784d | 0d |  | SIT | 6.33 | 6.11 | Green | Roger Robar | RED |  |
| 1030 | 1.4.1.4.3.3.5.17.10 | Update test cases |  | 5d | 2024-12-04 | 2024-12-10 | 1029 |  |  |  | 2024-12-04 | 2024-12-10 | 792d |  |  | SIT | 7.33 | 6.11 | Green | Roger Robar | RED |  |
| 1031 | 1.4.1.4.3.3.5.17.11 | Update RTTM |  | 5d | 2024-12-04 | 2024-12-10 | 1029 |  |  |  | 2024-12-04 | 2024-12-10 | 792d |  |  | SIT | 7.33 | 6.11 | Green | Roger Robar | RED |  |
| 1032 | 1.4.1.4.3.3.5.17.12 | Update master test case spreadsheet |  | 5d | 2024-12-04 | 2024-12-10 | 1029 |  |  |  | 2024-12-04 | 2024-12-10 | 784d | 0d |  | SIT | 7.33 | 6.11 | Green | Roger Robar | RED |  |
| 1033 | 1.4.1.4.3.3.5.17.13 | Issue to SITAG / SITAG paper day |  | 1d | 2024-12-11 | 2024-12-11 | 1032 |  |  |  | 2024-12-11 | 2024-12-11 | 784d | 0d |  | SIT | 14.33 | 6.11 | Green | Roger Robar | RED |  |
| 1034 | 1.4.1.4.3.3.5.17.14 | Prepare ADO update |  | 6d | 2024-12-11 | 2024-12-18 | 1032 |  |  |  | 2024-12-11 | 2024-12-18 | 786d |  |  | SIT | 14.33 | 6.11 | Green | Roger Robar | RED |  |
| 1035 | 1.4.1.4.3.3.5.17.15 | Sign off by SITAG | milestone | 0d | 2024-12-18 | 2024-12-18 | 1033FS+5d |  |  |  | 2024-12-18 | 2024-12-18 | 784d | 0d |  | SIT | 21.71 | 6.11 | Green | Roger Robar | RED |  |
| 1036 | 1.4.1.4.3.3.5.17.16 | Update ADO |  | 2d | 2024-12-19 | 2024-12-20 | 1035 |  |  |  | 2024-12-19 | 2024-12-20 | 784d | 0d |  | SIT | 22.33 | 6.11 | Green | Roger Robar | RED |  |
| 1037 | 1.4.1.4.3.3.5.17.17 | Update all ADO reporting |  | 2d | 2024-12-19 | 2024-12-20 | 1035 |  |  |  | 2024-12-19 | 2024-12-20 | 784d | 0d |  | SIT | 22.33 | 6.11 | Green | Roger Robar | RED |  |
| 1038 | 1.4.1.4.3.3.5.17.18 | Test Case Rationalisation complete | milestone | 0d | 2024-12-20 | 2024-12-20 | 1036, 1037 |  |  |  | 2024-12-20 | 2024-12-20 | 784d |  |  | SIT | 23.71 | 6.11 | Green | Roger Robar | RED | T3-TE-0123 |

Notes:
- 1038: 26/11/24 - Analysis and review more complex than anticipated, so Programme is reviewing Rationalisation (Functional + Migration) timeframes and will inform SITAG of this in December.

| ID | WBS | Task | Type | Duration | Start | Finish | Predecessors | Complete | Remaining | Baseline start | Baseline finish | Baseline duration | Baseline 1 start | Baseline 1 finish | Total slack | Constraint | Baseline cost | Responsible | Involved | Text9 | Update Version | MHHS Resource Name | MHHS Programme Phase | Sched Status | RAG | Milestone ID | Text29 | Tier | Artefact ID | Guidance |
| --- | --- | --- | --- | --- | --- | --- | --- | --- | --- | --- | --- | --- | --- | --- | --- | --- | --- | --- | --- | --- | --- | --- | --- | --- | --- | --- | --- | --- | --- | --- |
| 1039 | 1.4.1.4.3.4 | **Environments (SIT B)** |  | 435d | 2022-10-31 A | 2024-06-28 A |  | 100% |  | 2022-10-31 | 2024-06-28 | 420d | 2022-11-16 | 2024-05-13 |  |  | -0 | N/A | N/A | SIT | 5.0 | N/A | Systems Integration Testing (SIT) |  |  |  |  |  |  |  |
| 1040 | 1.4.1.4.3.4.1 | **PP Environments (SIT B)** |  | 41d | 2024-05-03 A | 2024-06-28 A |  | 100% |  | 2024-05-03 | 2024-06-28 | 26d | 2022-11-16 | 2024-05-13 |  |  | -0 | N/A | N/A | SIT | 5.0 | N/A | Systems Integration Testing (SIT) |  |  |  |  |  |  |  |
| 1041 | 1.4.1.4.3.4.1.1 | PP Environments available | milestone | 0d | 2024-05-03 A | 2024-05-03 A | 509 | 100% |  | 2024-05-03 | 2024-05-03 | 0d | 2022-11-16 | 2024-04-01 |  | start no earlier than 2024-05-03 |  | PP | SI Test | SIT | 5.21 | Simon Berry | Systems Integration Testing (SIT) | Complete | COMPLETE |  |  |  |  |  |
| 1042 | 1.4.1.4.3.4.1.2 | PP Onboarding / Smoke test |  | 35d | 2024-05-13 A | 2024-06-28 A | 1041FS+6d | 100% |  | 2024-05-13 | 2024-06-28 | 20d | 2022-11-16 | 2024-04-01 |  |  |  | PP | SI Test | SIT | 5.21 | Simon Berry | Systems Integration Testing (SIT) | Complete | COMPLETE |  |  |  |  |  |
| 1043 | 1.4.1.4.3.4.1.3 | DTN Connectivity Proving Complete |  | 5d | 2024-06-10 A | 2024-06-14 A | 1041FS+26d | 100% |  | 2024-06-10 | 2024-06-14 | 0d | 2024-04-15 | 2024-04-26 |  |  |  | PP | SI Test | SIT | 5.21 | Simon Berry | Systems Integration Testing (SIT) | Complete | COMPLETE |  |  |  |  |  |
| 1044 | 1.4.1.4.3.4.1.4 | PP Code Deployment | milestone | 0d | 2024-06-14 A | 2024-06-14 A | 1043 | 100% |  | 2024-06-14 | 2024-06-14 | 0d | 2024-04-29 | 2024-05-13 |  |  |  | PP | SI Test | SIT | 5.21 | Simon Berry | Systems Integration Testing (SIT) | Complete | COMPLETE |  |  |  |  |  |
| 1045 | 1.4.1.4.3.4.2 | **SI Environments (SIT B)** |  | 425d | 2022-10-31 A | 2024-06-14 A |  | 100% |  | 2022-10-31 | 2024-06-14 | 420d | 2022-11-16 | 2024-05-10 |  |  | -0 | N/A | N/A | SIT | 5.0 | N/A | Systems Integration Testing (SIT) |  |  |  |  |  |  |  |
| 1046 | 1.4.1.4.3.4.2.1 | Coordinate SIT Participants' SIT B environment preparation |  | 420d | 2022-10-31 A | 2024-06-07 A |  | 100% |  | 2022-10-31 | 2024-06-07 | 420d | 2022-11-16 | 2024-04-01 |  |  |  | SI Test | PP | SIT | 5.21 | Simon Berry | Systems Integration Testing (SIT) | Complete | COMPLETE |  |  |  |  |  |
| 1047 | 1.4.1.4.3.4.2.2 | Assure PPs' self-declaration of environment preparation complete (incl. security certificates and security compliance) | milestone | 0d | 2024-06-07 A | 2024-06-07 A | 1046 | 100% |  | 2024-06-07 | 2024-06-07 | 0d | 2022-11-16 | 2024-03-29 |  |  |  | SI Test | PP | SIT | 5.21 | Simon Berry | Systems Integration Testing (SIT) | Complete | COMPLETE |  |  |  |  |  |
| 1048 | 1.4.1.4.3.4.2.3 | SIT Participants' SIT B environments ready to start connectivity proving (incl. certificates and security compliance) | milestone | 0d | 2024-06-05 A | 2024-06-05 A | 1041FS+24d | 100% |  | 2024-06-05 | 2024-06-05 | 0d | 2024-04-01 | 2024-04-01 |  |  |  | SI Test | PP,IPA | SIT | 5.26 | Simon Berry | Systems Integration Testing (SIT) | Complete | COMPLETE | T3-TE-0033 | SITAG | T3 |  |  |
| 1049 | 1.4.1.4.3.4.2.4 | Coordinate SIT Participants' SIT B environment connectivity proving |  | 2d | 2024-06-06 A | 2024-06-07 A | 1048 | 100% |  | 2024-06-06 | 2024-06-07 | 19d | 2024-04-01 | 2024-04-26 |  |  |  | SI Test | PP | SIT | 5.21 | Simon Berry | Systems Integration Testing (SIT) | Complete | COMPLETE |  |  |  |  |  |
| 1050 | 1.4.1.4.3.4.2.5 | Coordinate deployment of MHHS solution code to SIT Participants' SIT B environments | milestone | 0d | 2024-06-14 A | 2024-06-14 A | 1044 | 100% |  | 2024-06-14 | 2024-06-14 | 4d | 2024-04-15 | 2024-04-26 |  |  |  | SI Test | PP | SIT | 5.21 | Simon Berry | Systems Integration Testing (SIT) | Complete | COMPLETE |  |  |  |  |  |
| 1051 | 1.4.1.4.3.5 | **SIT Migration Test Readiness Report** |  | 44d | 2024-04-02 A | 2024-05-31 A |  | 100% |  | 2024-04-02 | 2024-05-31 | 44d | 2024-04-02 | 2024-05-27 |  |  | -0 | N/A | N/A | SIT | 5.0 | N/A | Systems Integration Testing (SIT) |  |  |  |  |  |  |  |
| 1052 | 1.4.1.4.3.5.1 | **PP SIT Migration Test Readiness Report** |  | 44d | 2024-04-02 A | 2024-05-31 A |  | 100% |  | 2024-04-02 | 2024-05-31 | 44d | 2024-04-02 | 2024-05-13 |  |  | -0 | N/A | N/A | SIT | 5.0 | N/A | Systems Integration Testing (SIT) |  |  |  |  |  |  |  |
| 1053 | 1.4.1.4.3.5.1.1 | Develop draft Test Readiness Report and submit to Programme for assurance |  | 20d | 2024-04-02 A | 2024-04-29 A |  | 100% |  | 2024-04-02 | 2024-04-29 | 20d | 2024-04-02 | 2024-04-30 |  | start no earlier than 2024-04-02 |  | PP | SI Test | SIT | 5.0 |  | Systems Integration Testing (SIT) | Complete | COMPLETE |  |  |  |  |  |
| 1054 | 1.4.1.4.3.5.1.2 | Placing Reliance Stage 2 Review |  | 35d | 2024-04-15 A | 2024-05-31 A | 1053SS+9d | 100% |  | 2024-04-15 | 2024-05-31 | 35d |  |  |  |  |  | SI Test | PP | SIT | 5.12 |  | Systems Integration Testing (SIT) | Complete | COMPLETE |  |  |  |  |  |
| 1055 | 1.4.1.4.3.5.1.3 | Finalise Test Readiness Report and submit to Programme for assurance |  | 10d | 2024-04-30 A | 2024-05-13 A | 1053 | 100% |  | 2024-04-30 | 2024-05-13 | 10d | 2024-04-30 | 2024-05-13 |  |  |  | PP | SI Test | SIT | 5.0 |  | Systems Integration Testing (SIT) | Complete | COMPLETE |  |  |  |  |  |
| 1056 | 1.4.1.4.3.5.2 | **SI SIT Migration Test Readiness Report** |  | 40d | 2024-04-02 A | 2024-05-27 A |  | 100% |  | 2024-04-02 | 2024-05-27 | 40d | 2024-04-02 | 2024-05-27 |  |  |  | N/A | N/A | SIT | 5.0 | N/A | Systems Integration Testing (SIT) |  |  |  |  |  |  |  |
| 1057 | 1.4.1.4.3.5.2.1 | Assure Test Participants' Test Readiness Reports |  | 35d | 2024-04-02 A | 2024-05-20 A | 1053SS, 1055FF+5d | 100% |  | 2024-04-02 | 2024-05-20 | 35d | 2024-04-02 | 2024-05-20 |  |  |  | SI Test | PP,IPA | SIT | 5.0 |  | Systems Integration Testing (SIT) | Complete | COMPLETE |  |  |  |  |  |
| 1058 | 1.4.1.4.3.5.2.2 | Develop Overarching SIT Migration Test Readiness Report |  | 20d | 2024-04-23 A | 2024-05-20 A | 1057FF | 100% |  | 2024-04-23 | 2024-05-20 | 20d | 2024-04-23 | 2024-05-20 |  |  |  | SI Test |  | SIT | 5.0 |  | Systems Integration Testing (SIT) | Complete | COMPLETE |  |  |  |  |  |
| 1059 | 1.4.1.4.3.5.2.3 | Artefact review (via SITAG) and updates |  | 5d | 2024-05-21 A | 2024-05-27 A | 1058 | 100% |  | 2024-05-21 | 2024-05-27 | 5d | 2024-05-21 | 2024-05-27 |  |  |  | SI Test | PP,IPA | SIT | 5.0 |  | Systems Integration Testing (SIT) | Complete | COMPLETE |  |  |  |  |  |
| 1060 | 1.4.1.4.3.6 | SIT Migration Testing Preparation Complete | milestone | 0d | 2024-06-03 A | 2024-06-03 A | 1059FF+5d, 964, 372, 1054, 975, 981, 987 | 100% |  | 2024-06-03 | 2024-06-03 | 0d | 2024-06-03 | 2024-06-03 |  |  |  | SI Test | PP,IPA | SIT | 5.0 |  | Systems Integration Testing (SIT) | Complete | COMPLETE | T2-TE-0650 | SITAG | T2 |  |  |
| 1061 | 1.4.1.4.4 | **SIT Non-Functional Preparation** |  | 620d? | 2022-10-31 A | 2025-03-14 |  | 59% | 252.7d? | 2023-11-30 | 2025-03-14 | 193d | 2023-07-03 | 2024-08-26 | 724d |  | -0 | N/A | N/A | SIT | 5.0 | N/A | Systems Integration Testing (SIT) |  |  |  |  |  |  |  |
| 1062 | 1.4.1.4.4.1 | **Test Approach & Plan** |  | 120d | 2023-11-30 A | 2024-05-15 A |  | 100% |  | 2023-11-30 | 2024-05-15 | 120d | 2023-11-30 | 2024-03-20 |  |  | -0 | N/A | N/A | SIT | 5.0 | N/A | Systems Integration Testing (SIT) |  |  |  |  |  |  |  |
| 1063 | 1.4.1.4.4.1.1 | Develop document with SITWG |  | 67d | 2023-11-30 A | 2024-03-01 A |  | 100% |  | 2023-11-30 | 2024-03-01 | 67d | 2023-11-30 | 2024-01-10 |  | must start on 2023-11-30 |  | SI Test |  | SIT | 5.0 |  | Systems Integration Testing (SIT) | Complete | COMPLETE |  |  |  |  |  |
| 1064 | 1.4.1.4.4.1.2 | Draft document review with Code Bodies |  | 10d | 2024-03-04 A | 2024-03-15 A | 1063 | 100% |  | 2024-03-04 | 2024-03-15 | 10d | 2024-01-11 | 2024-01-24 |  |  |  | SI Test | Code Bodies | SIT | 5.0 |  | Systems Integration Testing (SIT) | Complete | COMPLETE |  |  |  |  |  |
| 1065 | 1.4.1.4.4.1.3 | Industry Consultation |  | 10d | 2024-03-18 A | 2024-03-29 A | 1064 | 100% |  | 2024-03-18 | 2024-03-29 | 10d |  |  |  |  |  | PP |  | SIT | 5.1 |  | Systems Integration Testing (SIT) | Complete | COMPLETE |  |  |  |  |  |
| 1066 | 1.4.1.4.4.1.4 | Industry Assurance Review |  | 5d | 2024-04-11 A | 2024-04-17 A | 1065FS+8d | 100% |  | 2024-04-11 | 2024-04-17 | 5d |  |  |  |  |  |  |  | SIT | 5.16 |  |  | Complete | COMPLETE |  |  |  |  |  |
| 1067 | 1.4.1.4.4.1.5 | SIT Non-Functional Testing Test Approach & Plan approved | milestone | 0d | 2024-05-15 A | 2024-05-15 A | 1066FS+20d | 100% |  | 2024-05-15 | 2024-05-15 | 0d | 2024-03-20 | 2024-03-20 |  |  |  | SI Test | PP | SIT | 5.30 | Roger Robar | Systems Integration Testing (SIT) | Complete | COMPLETE | T3-TE-0026 | SITAG | T3 | MHHS-ART073 | 30/7/24: Approved at esitag on 26/7/24 |

| ID | WBS | Task | Type | Duration | Start | Finish | Predecessors | Complete | Remaining | Actual finish | Baseline start | Baseline finish | Baseline duration | Baseline 1 start | Baseline 1 finish | Total slack | Free slack | Constraint | Baseline cost | Responsible | Involved | Text9 | Update Version | MHHS Resource Name | MHHS Programme Phase | Sched Status | RAG | Milestone ID | Text29 | Task Status | Guidance |
| --- | --- | --- | --- | --- | --- | --- | --- | --- | --- | --- | --- | --- | --- | --- | --- | --- | --- | --- | --- | --- | --- | --- | --- | --- | --- | --- | --- | --- | --- | --- | --- |
| 1068 | 1.4.1.4.4.2 | **Test Data Approach & Plan** |  | 41d | 2024-03-20 A | 2024-05-15 A |  | 100% |  |  | 2024-03-20 | 2024-05-15 | 41d | 2024-01-25 | 2024-03-20 |  |  |  | -0 | N/A | N/A | SIT | 5.0 | N/A | Systems Integration Testing (SIT) |  |  |  |  |  |  |
| 1069 | 1.4.1.4.4.2.1 | Industry Consultation |  | 14d | 2024-03-20 A | 2024-04-08 A | 1065SS+2d | 100% |  |  | 2024-03-20 | 2024-04-08 | 14d |  |  |  |  |  |  | PP |  | SIT | 5.1 | Richard Puddephatt | Systems Integration Testing (SIT) | Complete | COMPLETE |  |  |  |  |
| 1070 | 1.4.1.4.4.2.2 | Artefact review (via SITAG) and updates |  | 27d | 2024-04-09 A | 2024-05-15 A | 1069 | 100% |  |  | 2024-04-09 | 2024-05-15 | 27d | 2024-01-25 | 2024-03-13 |  |  |  |  | SI Test |  | SIT | 5.0 | Richard Puddephatt | Systems Integration Testing (SIT) | Complete | COMPLETE |  |  |  |  |
| 1071 | 1.4.1.4.4.2.3 | SIT Non-Functional Testing Test Data Approach & Plan approved | milestone | 0d | 2024-05-15 A | 2024-05-15 A | 1067FF, 1070 | 100% |  |  | 2024-05-15 | 2024-05-15 | 0d | 2024-03-20 | 2024-03-20 |  |  |  |  | SI Test | PP,IPA | SIT | 5.24 | Richard Puddephatt | Systems Integration Testing (SIT) | Complete | COMPLETE | T3-TE-0113 | SITAG |  |  |
| 1072 | 1.4.1.4.4.3 | **Test scenarios & Test Cases** |  | 98d? | 2024-03-04 A | 2024-07-17 |  | 78% | 21.17d? |  | 2024-03-04 | 2024-07-17 | 123d | 2023-07-24 | 2024-01-17 |  |  |  | -0 | N/A | N/A | SIT | 5.21 | N/A | Systems Integration Testing (SIT) |  |  |  |  |  |  |
| 1073 | 1.4.1.4.4.3.1 | **Theme 1** |  | 78d | 2024-03-04 A | 2024-06-19 A |  | 100% |  |  | 2024-03-04 | 2024-06-19 | 78d |  |  |  |  |  | -0 | N/A | N/A | SIT | 5.21 | N/A | Systems Integration Testing (SIT) |  |  |  |  | -448.67 |  |
| 1074 | 1.4.1.4.4.3.1.1 | Develop Test Scenarios & Test Cases |  | 33d | 2024-03-04 A | 2024-04-17 A | 1063 | 100% |  |  | 2024-03-04 | 2024-04-17 | 33d |  |  |  |  |  |  | SI Test | SI Test, PP | SIT | 5.21 |  |  | Complete | COMPLETE |  |  |  |  |
| 1075 | 1.4.1.4.4.3.1.2 | Industry Review Workshop |  | 1d | 2024-04-18 A | 2024-04-18 A | 1074 | 100% |  |  | 2024-04-18 | 2024-04-18 | 1d |  |  |  |  |  |  | SI Test, PP | SI Test, PP | SIT | 5.21 |  |  | Complete | COMPLETE |  |  |  |  |
| 1076 | 1.4.1.4.4.3.1.3 | Industry Consultation Review |  | 7d | 2024-05-02 A | 2024-05-10 A | 1075FS+9d | 100% |  |  | 2024-05-02 | 2024-05-10 | 7d |  |  |  |  |  |  | SI Test, PP | SI Test, PP | SIT | 5.21 |  |  | Complete | COMPLETE |  |  |  |  |
| 1077 | 1.4.1.4.4.3.1.4 | Review with NFT Working Group |  | 5d | 2024-05-31 A | 2024-06-06 A | 1076FS+14d | 100% |  |  | 2024-05-31 | 2024-06-06 | 5d |  |  |  |  |  |  | SI Test, PP | SI Test, PP | SIT | 5.21 |  |  | Complete | COMPLETE |  |  |  |  |
| 1078 | 1.4.1.4.4.3.1.5 | SIT NFT Scenarios & Test Cases Approved - Theme 1 | milestone | 0d | 2024-06-19 A | 2024-06-19 A | 1077FS+9d | 100% |  |  | 2024-06-19 | 2024-06-19 | 0d |  |  |  |  |  |  | SI Test | SI Test, PP | SIT | 5.30 | Roger Robar | Systems Integration Testing (SIT) | Complete | COMPLETE | T3-TE-0114 | SITAG |  | 30/7/24: Approved at esitag on 26/7/24 |
| 1079 | 1.4.1.4.4.3.2 | **Theme 2** |  | 98d | 2024-03-04 A | 2024-07-17 A |  | 100% |  |  | 2024-03-04 | 2024-07-17 | 98d |  |  |  |  |  |  | N/A | N/A | SIT | 5.21 | N/A | Systems Integration Testing (SIT) |  |  |  |  | -448.67 |  |
| 1080 | 1.4.1.4.4.3.2.1 | Develop Test Scenarios & Test Cases |  | 53d | 2024-03-04 A | 2024-05-15 A | 1063 | 100% |  |  | 2024-03-04 | 2024-05-15 | 53d |  |  |  |  |  |  | SI Test | SI Test, PP | SIT | 5.21 |  |  | Complete | COMPLETE |  |  |  |  |
| 1081 | 1.4.1.4.4.3.2.2 | Industry Review Workshop |  | 1d | 2024-05-16 A | 2024-05-16 A | 1080 | 100% |  |  | 2024-05-16 | 2024-05-16 | 1d |  |  |  |  |  |  | SI Test, PP | SI Test, PP | SIT | 5.21 |  |  | Complete | COMPLETE |  |  |  |  |
| 1082 | 1.4.1.4.4.3.2.3 | Industry Consultation Review |  | 7d | 2024-05-20 A | 2024-05-28 A | 1081FS+1d | 100% |  |  | 2024-05-20 | 2024-05-28 | 7d |  |  |  |  |  |  | SI Test, PP | SI Test, PP | SIT | 5.21 |  |  | Complete | COMPLETE |  |  |  |  |
| 1083 | 1.4.1.4.4.3.2.4 | Review with NFT Working Group |  | 5d | 2024-06-28 A | 2024-07-04 A | 1082FS+22d | 100% |  |  | 2024-06-28 | 2024-07-04 | 5d |  |  |  |  |  |  | SI Test, PP | SI Test, PP | SIT | 5.21 |  |  | Complete | COMPLETE |  |  |  |  |
| 1084 | 1.4.1.4.4.3.2.5 | SIT NFT Scenarios & Test Cases Approved - Theme 2 | milestone | 0d | 2024-07-17 A | 2024-07-17 A | 1083FS+9d | 100% |  |  | 2024-07-17 | 2024-07-17 | 0d |  |  |  |  |  |  | SI Test | SI Test, PP | SIT | 5.22 |  | Systems Integration Testing (SIT) | Complete | COMPLETE | T3-TE-0115 | SITAG |  |  |
| 1085 | 1.4.1.4.4.3.3 | **Theme 3** |  | 98d? | 2024-03-04 A | 2024-07-17 |  | 100% |  | 2024-09-18 | 2024-03-04 | 2024-07-17 | 123d |  |  |  |  |  | -0 | N/A | N/A | SIT | 6.0 | N/A | Systems Integration Testing (SIT) |  |  |  |  | -448.67 |  |
| 1086 | 1.4.1.4.4.3.3.1 | Develop Test Scenarios & Test Cases |  | 63d | 2024-03-04 A | 2024-05-29 A | 1063 | 100% |  |  | 2024-03-04 | 2024-05-29 | 63d |  |  |  |  |  |  | SI Test | SI Test, PP | SIT | 6.0 |  |  | Complete | COMPLETE |  |  |  |  |
| 1087 | 1.4.1.4.4.3.3.2 | Industry Review Workshop |  | 1d | 2024-05-30 A | 2024-05-30 A | 1086 | 100% |  |  | 2024-05-30 | 2024-05-30 | 1d |  |  |  |  |  |  | SI Test, PP | SI Test, PP | SIT | 6.0 |  |  | Complete | COMPLETE |  |  |  |  |
| 1088 | 1.4.1.4.4.3.3.3 | Industry Consultation Review |  | 6d | 2024-06-10 A | 2024-06-17 A | 1087FS+6d | 100% |  |  | 2024-06-10 | 2024-06-17 | 6d |  |  |  |  |  |  | SI Test, PP | SI Test, PP | SIT | 6.0 |  |  | Complete | COMPLETE |  |  |  |  |
| 1089 | 1.4.1.4.4.3.3.4 | Review with NFT Working Group |  | 5d | 2024-06-28 A | 2024-07-04 A | 1088FS+8d | 100% |  |  | 2024-06-28 | 2024-07-04 | 30d |  |  |  |  |  |  | SI Test, PP | SI Test, PP | SIT | 6.0 | Roger Robar |  | Complete | COMPLETE |  |  |  |  |
| 1090 | 1.4.1.4.4.3.3.5 | SIT NFT Scenarios & Test Cases Approved - Theme 3 | milestone | 0d | 2024-09-18 A | 2024-09-18 A | 1089FS+9d | 100% |  |  | 2024-09-18 | 2024-09-18 | 0d |  |  |  |  | start no earlier than 2024-09-18 |  | SI Test | SI Test, PP | SIT | 5.30 | Roger Robar | Systems Integration Testing (SIT) | Complete | COMPLETE | T3-TE-0116 | SITAG |  | 31/7/24: baseline date change approved at esitag on 26/7/24 |
| 1091 | 1.4.1.4.4.3.4 | **SIT NFT Programme RTTM** |  | 56d? | 2024-09-18 A | 2024-12-04 |  | 78% | 12.39d? |  | 2024-09-18 | 2024-10-16 | 0d |  |  | 796d |  |  |  |  |  | SIT | 6.11 | David O'Riordan |  | Overdue Start |  |  |  | -197.67 |  |
| 1092 | 1.4.1.4.4.3.4.1 | Develop Manual SIT NFT RTTM |  | 30d | 2024-09-18 A | 2024-10-29 A | 1090 | 100% |  |  | 2024-09-18 | 2024-10-29 | 0d |  |  |  |  |  |  |  |  | SIT | 6.11 | David O'Riordan |  | Complete | COMPLETE |  |  |  |  |
| 1093 | 1.4.1.4.4.3.4.2 | LDP peer review |  | 10d | 2024-10-30 A | 2024-11-12 A | 1092 | 100% |  |  | 2024-10-30 | 2024-11-12 | 0d |  |  |  |  |  |  |  |  | SIT | 6.11 | David O'Riordan |  | Complete | COMPLETE |  |  |  |  |
| 1094 | 1.4.1.4.4.3.4.3 | Review with SRO |  | 5d | 2024-11-13 A | 2024-11-19 A | 1093 | 100% |  |  | 2024-11-13 | 2024-11-19 | 0d |  |  |  |  |  |  |  |  | SIT | 6.11 | David O'Riordan |  | Complete | COMPLETE |  |  |  |  |
| 1095 | 1.4.1.4.4.3.4.4 | DIP Manager / Code Bodies / Full SRO to review |  | 5d | 2024-11-13 A | 2024-11-19 | 1093 | 50% | 2.5d |  | 2024-11-13 | 2024-11-19 | 0d |  |  | 742d | 0d |  |  |  |  |  | 6.12 | David O'Riordan |  | Green | RED |  |  |  |  |
| 1096 | 1.4.1.4.4.3.4.5 | Manual SIT NFT RTTM Complete | milestone | 0d | 2024-11-19 | 2024-11-19 | 1094, 1095 |  |  |  | 2024-11-19 | 2024-11-19 | 0d |  |  | 742d | 0d |  |  |  |  | SIT | 6.11 | David O'Riordan |  | Green | RED |  |  | -7.29 |  |
| 1097 | 1.4.1.4.4.3.4.6 | Develop Automated SIT NFT RTTM |  | 10d | 2024-11-20 | 2024-12-03 | 1096 |  |  |  | 2024-11-20 | 2024-12-03 | 0d |  |  | 742d | 0d |  |  |  |  | SIT | 6.11 | David O'Riordan |  | Green | GREEN |  |  | -6.67 |  |
| 1098 | 1.4.1.4.4.3.4.7 | Review with SRO |  | 1d? | 2024-12-04 | 2024-12-04 | 1097 |  |  |  | 2024-12-04 | 2024-12-04 | 0d |  |  | 796d |  |  |  |  |  | SIT | 6.11 | David O'Riordan |  | Green | GREEN |  |  | 7.33 |  |
| 1099 | 1.4.1.4.4.3.4.8 | Automated SIT NFT RTTM Complete | milestone | 0d | 2024-12-03 | 2024-12-03 | 1097 |  |  |  | 2024-12-03 | 2024-12-03 | 0d |  |  | 797d |  |  |  |  |  | SIT | 6.11 | David O'Riordan |  | Green | GREEN |  |  | 6.71 |  |

Notes:
- 1095: 25/11/24 - Out for review with all but no formal response / comments received.

| ID | WBS | Task | Type | Duration | Start | Finish | Predecessors | Complete | Remaining | Baseline start | Baseline finish | Baseline duration | Total slack | Free slack | Constraint | Responsible | Text9 | Task Status | Update Version | Sched Status | MHHS Resource Name | Text29 | RAG |
| --- | --- | --- | --- | --- | --- | --- | --- | --- | --- | --- | --- | --- | --- | --- | --- | --- | --- | --- | --- | --- | --- | --- | --- |
| 1100 | 1.4.1.4.4.3.5 | **Gap analysis** |  | 45d? | 2024-12-18 | 2025-02-18 |  |  |  | 2024-08-26 | 2024-10-11 | 0d | 742d |  |  | SI Test | SIT | -693.67 | 6.13 | Overdue Start | David O'Riordan | SITAG |  |
| 1101 | 1.4.1.4.4.3.5.1 | Identify gaps in test case coverage following RTTM review |  | 1d? | 2024-12-18 | 2024-12-18 | 1097SS+20d |  |  | 2024-12-18 | 2024-12-18 |  | 742d | 0d |  |  |  | 21.33 |  | Green | David O'Riordan |  | GREEN |
| 1102 | 1.4.1.4.4.3.5.2 | Address gaps in test case coverage following RTTM review |  | 25d | 2024-12-19 | 2025-01-22 | 1101 |  |  | 2024-12-19 | 2025-01-22 | 0d | 742d | 0d |  | SI Test | SIT | 22.33 | 6.13 | Green | David O'Riordan | SITAG | GREEN |
| 1103 | 1.4.1.4.4.3.5.3 | Gap analysis complete | milestone | 0d | 2025-01-22 | 2025-01-22 | 1102 |  |  | 2025-01-22 | 2025-01-22 | 0d | 742d | 0d |  | SI Test | SIT | 56.71 | 6.13 | Green | David O'Riordan | SITAG | GREEN |
| 1104 | 1.4.1.4.4.3.5.4 | Test Script updates identified |  | 1d? | 2025-01-23 | 2025-01-23 | 1103 |  |  | 2025-01-23 | 2025-01-23 | 0d | 742d | 0d |  | SI Test | SIT | 57.33 | 6.13 | Green | David O'Riordan | SITAG | GREEN |
| 1105 | 1.4.1.4.4.3.5.5 | Test Scripts updates |  | 1d | 2025-01-24 | 2025-01-24 | 1104 |  |  | 2025-01-24 | 2025-01-24 | 0d | 759d |  |  | SI Test | SIT | 58.33 | 6.13 | Green | David O'Riordan | SITAG | GREEN |
| 1106 | 1.4.1.4.4.3.5.6 | RTTM Updated Additional Static RTTM WBS items |  | 10d | 2025-01-23 | 2025-02-05 | 1104FS-1d |  |  | 2025-01-23 | 2025-02-05 | 0d | 742d | 0d |  | SI Test | SIT | 57.33 | 6.13 | Green | David O'Riordan | SITAG | GREEN |
| 1107 | 1.4.1.4.4.3.5.7 | Removal of de-scoped TCs from the RTTMs |  | 5d | 2025-01-30 | 2025-02-05 | 1106FS-5d |  |  | 2025-01-30 | 2025-02-05 | 0d | 751d |  |  | SI Test | SIT | 64.33 | 6.13 | Green | David O'Riordan | SITAG | GREEN |
| 1108 | 1.4.1.4.4.3.5.8 | Update and stabilisation of all TC ADO IDs |  | 14d | 2025-01-30 | 2025-02-18 | 1106FS-5d |  |  | 2025-01-30 | 2025-02-18 | 0d | 742d |  |  | SI Test | SIT | 64.33 | 6.13 | Green | David O'Riordan | SITAG | GREEN |
| 1109 | 1.4.1.4.4.3.5.9 | Addition and integration of Role tags to reqs in the Role RTTMs |  | 5d | 2025-01-30 | 2025-02-05 | 1106FS-5d |  |  | 2025-01-30 | 2025-02-05 | 0d | 751d |  |  | SI Test | SIT | 64.33 | 6.13 | Green | David O'Riordan | SITAG | GREEN |
| 1110 | 1.4.1.4.4.3.5.10 | Update of the RTTM All sheet (porting of the individual RTTMs) |  | 7d | 2025-02-04 | 2025-02-12 | 1106FS-2d |  |  | 2025-02-04 | 2025-02-12 | 0d | 746d | 0d |  | SI Test | SIT | 69.33 | 6.13 | Green | David O'Riordan | SITAG | GREEN |
| 1111 | 1.4.1.4.4.3.5.11 | Define Additional ADO Tags |  | 1d | 2025-02-03 | 2025-02-03 | 1106FS-3d |  |  | 2025-02-03 | 2025-02-03 | 0d | 753d |  |  | SI Test | SIT | 68.33 | 6.13 | Green | David O'Riordan | SITAG | GREEN |
| 1112 | 1.4.1.4.4.3.5.12 | Functional RTTM ready for import into ADO | milestone | 0d | 2025-02-12 | 2025-02-12 | 1110 |  |  | 2025-02-12 | 2025-02-12 | 0d | 746d |  |  | SI Test | SIT | 77.71 | 6.13 | Green | David O'Riordan | SITAG | GREEN |
| 1113 | 1.4.1.4.4.3.5.13 | Further Interative Deepdive on the requirements to testcase mapping |  | 9d | 2025-01-30 | 2025-02-11 | 1110FS-10d |  |  | 2025-01-30 | 2025-02-11 | 0d | 747d | 0d |  | SI Test | SIT | 64.33 | 6.13 | Green | David O'Riordan | SITAG | GREEN |
| 1114 | 1.4.1.4.4.3.5.14 | Internal review |  | 5d | 2025-01-30 | 2025-02-05 | 1113FS-9d |  |  | 2025-01-30 | 2025-02-05 | 0d | 749d | 0d |  | SI Test | SIT | 64.33 | 6.13 | Green | David O'Riordan | SITAG | GREEN |
| 1115 | 1.4.1.4.4.3.5.15 | Issue Static RTTM to Code Bodies |  | 1d? | 2025-02-07 | 2025-02-07 | 1114FS+1d |  |  | 2025-02-07 | 2025-02-07 | 0d | 749d | 0d |  | SI Test | SIT | 72.33 | 6.13 | Green | David O'Riordan | SITAG | GREEN |
| 1116 | 1.4.1.4.4.3.5.16 | Code Body Acceptance of RTTM | milestone | 0d | 2025-02-07 | 2025-02-07 | 1115 |  |  | 2024-10-30 | 2025-02-10 | 0d | 749d |  |  | Code Bodies | SIT | 72.71 | 6.13 | Green | David O'Riordan |  | GREEN |
| 1117 | 1.4.1.4.4.3.6 | **DITL** |  | 8d? | 2024-10-08 | 2024-10-17 |  |  |  | 2024-10-08 | 2024-10-17 | 0d | 830d |  |  | SI Test | SIT | 6.33 | 6.13 | No BL | Dom Mooney |  |  |
| 1118 | 1.4.1.4.4.3.6.1 | Programme Cycle 2 Retro |  | 1d? | 2024-10-08 | 2024-10-08 |  |  |  | 2024-10-08 | 2024-10-08 | 0d | 830d | 0d | start no earlier than 2024-10-08 | SI Test | SIT | -49.67 | 6.13 | Overdue Start | Dom Mooney |  | RED |
| 1119 | 1.4.1.4.4.3.6.2 | Post-retro DITL Changes |  | 3d | 2024-10-09 | 2024-10-11 | 1118 |  |  | 2024-10-09 | 2024-10-11 | 0d | 830d | 0d |  | SI Test | SIT | -48.67 | 6.13 | Overdue Start | Dom Mooney |  | RED |
| 1120 | 1.4.1.4.4.3.6.3 | SRO Review |  | 2d | 2024-10-14 | 2024-10-15 | 1119 |  |  | 2024-10-14 | 2024-10-15 | 0d | 830d | 0d |  | SI Test | SIT | -43.67 | 6.13 | Overdue Start | Dom Mooney |  | RED |
| 1121 | 1.4.1.4.4.3.6.4 | Post-SRO Review Changes |  | 1d? | 2024-10-16 | 2024-10-16 | 1120 |  |  | 2024-10-16 | 2024-10-16 | 0d | 830d | 0d |  | SI Test | SIT | -41.67 | 6.13 | Overdue Start | Dom Mooney |  | RED |
| 1122 | 1.4.1.4.4.3.6.5 | Publish Cycle 3 DITL / Cycle 3 DITL Online Sessions for SIT PPs |  | 1d? | 2024-10-17 | 2024-10-17 | 1121 |  |  | 2024-10-17 | 2024-10-17 | 0d | 830d |  |  | SI Test, PPs | SIT | -40.67 | 6.13 | Overdue Start | Dom Mooney |  | RED |
| 1123 | 1.4.1.4.4.3.7 | **NFT Performance Tool Theme 1 Setup** |  | 223d? | 2024-03-04 A | 2025-01-08 |  | 98% | 4.03d? | 2024-03-04 | 2025-01-10 | 0d | 771d |  |  |  | SIT | -205.67 | 6.1 | Overdue Start | David O'Riordan |  |  |
| 1124 | 1.4.1.4.4.3.7.1 | Theme 1 injection tool initial POC |  | 85d? | 2024-03-04 A | 2024-06-28 A |  | 100% |  | 2024-03-04 | 2024-06-28 | 0d |  |  |  |  | SIT |  | 6.1 | Complete | David O'Riordan |  | COMPLETE |
| 1125 | 1.4.1.4.4.3.7.2 | Theme 1 injection tool configuration and validation against DIP SIM (IR7.1) |  | 38d | 2024-07-01 A | 2024-08-21 A | 1124 | 100% |  | 2024-07-01 | 2024-08-21 | 0d |  |  |  |  | SIT |  | 6.1 | Complete | David O'Riordan |  | COMPLETE |
| 1126 | 1.4.1.4.4.3.7.3 | Theme 1 injection tool configuration and validation against DIP SIM (IR8.1) |  | 29d | 2024-08-22 A | 2024-10-01 A | 1125 | 100% |  | 2024-08-22 | 2024-10-01 | 0d |  |  |  |  | SIT |  | 6.1 | Complete | David O'Riordan |  | COMPLETE |
| 1127 | 1.4.1.4.4.3.7.4 | Theme 1 injection tool configuration and validation againast UIT DIP (IR8.1) |  | 11d | 2024-10-02 A | 2024-10-16 A | 1126 | 100% |  | 2024-10-02 | 2024-10-16 | 0d |  |  |  |  | SIT |  | 6.1 | Complete | David O'Riordan |  | COMPLETE |
| 1128 | 1.4.1.4.4.3.7.5 | Theme 1 injection tool configuration and validation against SIT-B DIP (IR8.3) |  | 3d? | 2025-01-06 | 2025-01-08 | 1488FS+10d |  |  | 2025-01-06 | 2025-01-08 | 0d | 771d |  |  |  | SIT | 40.33 | 6.1 | Green | David O'Riordan |  | GREEN |

Notes:
- 1101: 27/11/24 - Programme is updating these timeframes.
- 1102: 27/11/24 - Programme is updating these timeframes.
- 1103: 27/11/24 - Programme is updating these timeframes.
- 1104: 27/11/24 - Programme is updating these timeframes.
- 1105: 27/11/24 - Programme is updating these timeframes.
- 1106: 27/11/24 - Programme is updating these timeframes.
- 1107: 27/11/24 - Programme is updating these timeframes.
- 1108: 27/11/24 - Programme is updating these timeframes.
- 1109: 27/11/24 - Programme is updating these timeframes.
- 1110: 27/11/24 - Programme is updating these timeframes.
- 1111: 27/11/24 - Programme is updating these timeframes.
- 1112: 27/11/24 - Programme is updating these timeframes.
- 1113: 27/11/24 - Programme is updating these timeframes.
- 1114: 27/11/24 - Programme is updating these timeframes.
- 1115: 27/11/24 - Programme is updating these timeframes.
- 1116: 27/11/24 - Programme is updating these timeframes.
- 1117: 27/11/24 - Programme is updating these timeframes.
- 1118: 27/11/24 - Programme is updating these timeframes.
- 1119: 27/11/24 - Programme is updating these timeframes.
- 1120: 27/11/24 - Programme is updating these timeframes.
- 1121: 27/11/24 - Programme is updating these timeframes.
- 1122: 27/11/24 - Programme is updating these timeframes.

| ID | WBS | Task | Type | Duration | Start | Finish | Predecessors | Complete | Remaining | Baseline start | Baseline finish | Baseline duration | Baseline 1 start | Baseline 1 finish | Total slack | Free slack | Constraint | Baseline cost | Responsible | Involved | Text9 | Update Version | MHHS Resource Name | MHHS Programme Phase | Action | Sched Status | RAG | Task Status | Milestone ID |
| --- | --- | --- | --- | --- | --- | --- | --- | --- | --- | --- | --- | --- | --- | --- | --- | --- | --- | --- | --- | --- | --- | --- | --- | --- | --- | --- | --- | --- | --- |
| 1129 | 1.4.1.4.4.4 | **Environments (SIT B)** |  | 94d? | 2024-08-27 A | 2025-01-03 |  |  | 94d? | 2024-08-27 | 2025-01-03 | 0d | 2024-07-30 | 2024-08-05 | 61d |  |  | -0 | N/A | N/A | SIT | 5.0 | Heath Thomas | Systems Integration Testing (SIT) |  |  |  |  |  |
| 1130 | 1.4.1.4.4.4.1 | **PP Environments (SIT B)** |  | 0d | 2024-08-27 A | 2024-08-27 A |  | 100% |  | 2024-08-27 | 2024-08-27 | 0d | 2024-07-30 | 2024-08-05 |  |  |  | -0 | N/A | N/A | SIT | 5.0 | Heath Thomas | Systems Integration Testing (SIT) |  |  |  |  |  |
| 1131 | 1.4.1.4.4.4.1.1 | Deployment of MHHS solution code to SIT B environments | milestone | 0d | 2024-08-27 A | 2024-08-27 A |  | 100% |  | 2024-08-27 | 2024-08-27 | 0d | 2024-07-30 | 2024-08-05 |  |  | start no earlier than 2024-08-27 |  | PP | SI Test | SIT | 5.21 | Heath Thomas | Systems Integration Testing (SIT) | 26/3/24: Lee said change to SB and align to IR7 | Complete | COMPLETE |  |  |
| 1132 | 1.4.1.4.4.4.2 | **SI Environments (SIT B)** |  | 0d | 2024-08-27 A | 2024-08-27 A |  | 100% |  | 2024-08-27 | 2024-08-27 | 0d | 2024-07-30 | 2024-08-05 |  |  |  | -0 | N/A | N/A | SIT | 5.0 | Heath Thomas | Systems Integration Testing (SIT) |  |  |  |  |  |
| 1133 | 1.4.1.4.4.4.2.1 | Coordinate deployment of MHHS solution code to SIT Participants' SIT B environments | milestone | 0d | 2024-08-27 A | 2024-08-27 A | 1131SS | 100% |  | 2024-08-27 | 2024-08-27 | 0d | 2024-07-30 | 2024-08-05 |  |  |  |  | SI Test | PP | SIT | 5.21 | Heath Thomas | Systems Integration Testing (SIT) |  | Complete | COMPLETE |  |  |
| 1134 | 1.4.1.4.4.4.3 | **Helix and Avanade Environments Upscale** |  | 10d? | 2024-12-23 | 2025-01-03 |  |  |  | 2024-12-23 | 2025-01-03 | 0d |  |  | 61d |  |  |  |  |  | SIT | 6.0 | Heath Thomas |  |  | Overdue Start |  | -686.67 |  |
| 1135 | 1.4.1.4.4.4.3.1 | Environment Uplift Window |  | 10d? | 2024-12-23 | 2025-01-03 | 1479 |  |  | 2024-12-23 | 2025-01-03 | 0d |  |  | 61d | 0d |  |  |  |  | SIT | 6.0 |  |  |  | Green | GREEN | 26.33 |  |
| 1136 | 1.4.1.4.4.5 | **Test Data - Non-Functional and Operational (SIT B)** |  | 50d? | 2025-01-06 | 2025-03-14 |  |  |  | 2025-01-06 | 2025-03-14 | 0d |  |  | 61d |  |  |  |  |  | SIT | 6.0 |  |  |  | Overdue Start |  | -686.67 |  |
| 1137 | 1.4.1.4.4.5.1 | **Data Load** |  | 50d? | 2025-01-06 | 2025-03-14 |  |  |  | 2025-01-06 | 2025-03-14 | 0d |  |  | 61d |  |  |  |  |  | SIT | 6.0 | Richard Puddephatt |  |  | Overdue Start |  | -689.67 |  |
| 1138 | 1.4.1.4.4.5.1.1 | Non-Functional Theme 1 (Avenade) Data Load |  | 5d? | 2025-01-06 | 2025-01-10 | 1135 |  |  | 2025-01-06 | 2025-01-10 | 0d |  |  | 61d | 0d |  |  |  |  | SIT | 6.0 | Richard Puddephatt |  |  | Green | GREEN | 40.33 | T3-TE-0126 |
| 1139 | 1.4.1.4.4.5.1.2 | Non-Functional Theme 2 & 3 (Helix, Avenade & PPs) Data Load |  | 5d | 2025-02-03 | 2025-02-07 | 1546 |  |  | 2025-02-03 | 2025-02-07 | 0d |  |  | 71d | 0d |  |  |  |  | SIT | 6.0 | Richard Puddephatt |  |  | Green | GREEN | 68.33 | T3-TE-0127 |
| 1140 | 1.4.1.4.4.5.1.3 | Non-Functional Themes 2 & 3 (LDSO's and DCC) Data Load |  | 20d? | 2025-01-06 | 2025-01-31 | 1135 |  |  | 2025-01-06 | 2025-01-31 | 0d |  |  | 101d | 20d |  |  |  |  | SIT | 6.0 | Richard Puddephatt |  |  | Green | GREEN | 40.33 | T3-TE-0128 |
| 1141 | 1.4.1.4.4.5.1.4 | Operational Themes 1, 2 & 3 (Batch 2) (LDSO's and DCC) Data Load |  | 20d? | 2025-01-06 | 2025-01-31 | 1135 |  |  | 2025-01-06 | 2025-01-31 | 0d |  |  | 66d | 5d | start no earlier than 2025-01-06 |  |  |  | SIT | 6.0 | Richard Puddephatt |  |  | Green | GREEN | 40.33 | T3-TE-0129 |
| 1142 | 1.4.1.4.4.5.1.5 | Operational Themes 1, 2 & 3 (Batch 2) (Helix, Avenade & PPs) Data Load |  | 5d | 2025-02-03 | 2025-02-07 | 1546 |  |  | 2025-02-03 | 2025-02-07 | 0d |  |  | 61d | 0d |  |  |  |  | SIT | 6.0 | Richard Puddephatt |  |  | Green | GREEN | 68.33 | T3-TE-0130 |
| 1143 | 1.4.1.4.4.5.1.6 | Non-Functional and Operational Test Data Preparation Complete | milestone | 0d | 2025-02-07 | 2025-02-07 | 1142 |  |  | 2025-02-07 | 2025-02-07 | 0d |  |  | 749d |  |  |  |  |  | SIT | 6.0 | Richard Puddephatt |  |  | Green | GREEN | 72.71 | T3-TE-0131 |
| 1144 | 1.4.1.4.4.5.1.7 | Non-Functional Theme 2 & 3 PP Preparation |  | 25d? | 2025-02-10 | 2025-03-14 | 1139 |  |  | 2025-02-10 | 2025-03-14 | 0d |  |  | 71d | 0d |  |  |  |  | SIT | 6.0 | Richard Puddephatt |  |  | Green | GREEN | 75.33 |  |
| 1145 | 1.4.1.4.4.6 | **SIT Non-Functional Test Readiness Report** |  | 575d? | 2022-10-31 A | 2025-01-10 |  | 22% | 451.15d? | 2024-06-25 | 2025-03-07 | 44d | 2024-06-25 | 2024-08-19 | 769d |  |  | -0 | N/A | N/A | SIT | 5.0 | Roger Robar | Systems Integration Testing (SIT) |  |  |  |  |  |
| 1146 | 1.4.1.4.4.6.1 | **PP SIT Non-Functional Test Readiness Report** |  | 124d | 2024-06-25 A | 2024-12-13 |  | 22% | 97d | 2024-06-25 | 2025-03-07 | 44d | 2024-06-25 | 2024-08-05 | 7d |  |  | -0 | N/A | N/A | SIT | 5.0 | Roger Robar | Systems Integration Testing (SIT) |  |  |  |  |  |
| 1147 | 1.4.1.4.4.6.1.1 | Develop draft Test Readiness Report and submit to Programme for assurance |  | 20d | 2024-06-25 A | 2024-07-22 A |  | 100% |  | 2024-06-25 | 2024-07-22 | 20d | 2024-06-25 | 2024-07-22 |  |  | start no earlier than 2024-06-25 |  | PP | SI Test | SIT | 5.0 | Roger Robar | Systems Integration Testing (SIT) |  | Complete | COMPLETE |  |  |
| 1148 | 1.4.1.4.4.6.1.2 | Finalise Test Readiness Report and submit to Programme for assurance |  | 104d | 2024-07-23 A | 2024-12-13 | 1147 | 7% | 97d | 2024-07-23 | 2024-12-13 | 10d | 2024-07-23 | 2024-08-05 | 7d | 0d |  |  | PP | SI Test | SIT | 5.0 | Roger Robar | Systems Integration Testing (SIT) |  | Green | GREEN |  |  |
| 1149 | 1.4.1.4.4.6.2 | **SI SIT Non-Functional Test Readiness Report** |  | 144d | 2024-06-25 A | 2025-01-10 |  | 22% | 112.84d | 2024-06-25 | 2025-01-10 | 40d | 2024-06-25 | 2024-08-19 | 151d |  |  |  | N/A | N/A | SIT | 5.0 | Roger Robar | Systems Integration Testing (SIT) |  |  |  |  |  |
| 1150 | 1.4.1.4.4.6.2.1 | Assure Test Participants' Test Readiness Reports |  | 114d | 2024-06-25 A | 2024-12-13 | 1147SS, 1148FF | 19% | 92d | 2024-06-25 | 2024-12-13 | 35d | 2024-06-25 | 2024-08-12 | 7d | 0d |  |  | SI Test | PP,IPA | SIT | 5.0 | Roger Robar | Systems Integration Testing (SIT) |  | Green | GREEN |  |  |
| 1151 | 1.4.1.4.4.6.2.2 | Develop Overarching SIT Non-Functional Test Readiness Report |  | 15d | 2024-12-02 A | 2024-12-20 | 1150FS-10d | 47% | 8d | 2024-12-02 | 2024-12-20 | 20d | 2024-07-16 | 2024-08-12 | 151d | 0d |  |  | SI Test |  | SIT | 5.0 | Roger Robar | Systems Integration Testing (SIT) |  | Green | GREEN |  |  |
| 1152 | 1.4.1.4.4.6.2.3 | Artefact review (via SITAG / SRO) and updates |  | 5d | 2025-01-06 | 2025-01-10 | 1151FS+10d |  |  | 2025-01-06 | 2025-01-10 | 5d | 2024-08-13 | 2024-08-19 | 136d | 0d |  |  | SI Test | PP,IPA | SIT | 5.0 | Roger Robar | Systems Integration Testing (SIT) |  | Green | GREEN | 40.33 |  |

Notes:
- 1148: 10/10/24 - Duration extended to 94 days.

| ID | WBS | Task | Type | Duration | Start | Finish | Predecessors | Complete | Remaining | Baseline start | Baseline finish | Baseline duration | Baseline 1 start | Baseline 1 finish | Total slack | Free slack | Constraint | Baseline cost | Text9 | Task Status | Update Version | Sched Status | MHHS Resource Name | RAG | Responsible | Involved | MHHS Programme Phase | Milestone ID | Text29 | Tier | Artefact ID | Guidance |
| --- | --- | --- | --- | --- | --- | --- | --- | --- | --- | --- | --- | --- | --- | --- | --- | --- | --- | --- | --- | --- | --- | --- | --- | --- | --- | --- | --- | --- | --- | --- | --- | --- |
| 1153 | 1.4.1.4.4.6.3 | **Progress reporting** |  | 1d? | 2022-10-31 | 2022-10-31 |  |  |  |  |  |  |  |  | 1343d |  |  |  | SIT | -738.67 | 6.12 | Overdue Start | Roger Robar | RED |  |  |  |  |  |  |  |  |
| 1154 | 1.4.1.4.4.6.3.1 | Determine methodology |  | 1d? | 2022-10-31 | 2022-10-31 |  |  |  |  |  |  |  |  | 1343d |  |  |  | SIT | -757.67 | 6.12 | Overdue Start | Roger Robar | RED |  |  |  |  |  |  |  |  |
| 1155 | 1.4.1.4.4.6.3.2 | Implement reporting |  | 1d? | 2022-10-31 | 2022-10-31 |  |  |  |  |  |  |  |  | 1343d |  |  |  | SIT | -757.67 | 6.12 | Overdue Start | Roger Robar | RED |  |  |  |  |  |  |  |  |
| 1156 | 1.4.1.4.4.7 | SIT Non-Functional Testing Preparation Complete Theme 1 | milestone | 0d | 2025-01-10 | 2025-01-10 | 1152FF, 834, 389, 1078, 1084, 1090 |  |  | 2025-03-07 | 2025-03-07 | 0d | 2024-08-26 | 2024-08-26 | 151d | 40d |  |  | SIT | 44.71 | 6.13 | Green | Roger Robar | AMBER | SI Test | PP,IPA | Systems Integration Testing (SIT) | T2-TE-0700 | SITAG | T2 |  |  |
| 1157 | 1.4.1.4.4.8 | SIT Non-Functional Testing Preparation Complete Theme 2 & 3 | milestone | 0d | 2025-02-28 | 2025-02-28 | 1139, 1140, 390FS+5d |  |  |  |  |  |  |  | 734d |  |  |  | SIT | 93.71 | 6.13 | No BL |  | GREEN |  |  |  | T2-TE-1100 |  |  |  |  |
| 1158 | 1.4.1.4.5 | **SIT Operational Preparation** |  | 654d? | 2022-10-31 A | 2025-05-01 |  | 42% | 377.91d? | 2024-02-01 | 2025-01-31 | 283d | 2023-08-03 | 2025-03-10 | 690d |  |  | -0 | SIT |  | 5.0 |  | N/A |  | N/A | N/A | Systems Integration Testing (SIT) |  |  |  |  |  |
| 1159 | 1.4.1.4.5.1 | **Test Approach & Plan** |  | 75d | 2024-02-01 A | 2024-05-15 A |  | 100% |  | 2024-02-01 | 2024-05-15 | 75d | 2024-02-01 | 2024-05-15 |  |  |  | -0 | SIT |  | 5.0 |  | N/A |  | N/A | N/A | Systems Integration Testing (SIT) |  |  |  |  |  |
| 1160 | 1.4.1.4.5.1.1 | Develop document with SITWG |  | 25d | 2024-02-01 A | 2024-03-06 A |  | 100% |  | 2024-02-01 | 2024-03-06 | 25d | 2024-02-01 | 2024-03-06 |  |  | must start on 2024-02-01 |  | SIT |  | 5.0 | Complete |  | COMPLETE | SI Test |  | Systems Integration Testing (SIT) |  |  |  |  |  |
| 1161 | 1.4.1.4.5.1.2 | Draft document review with Code Bodies |  | 4d | 2024-03-21 A | 2024-03-26 A | 1160FS+10d | 100% |  | 2024-03-21 | 2024-03-26 | 10d | 2024-03-07 | 2024-03-20 |  |  |  |  | SIT |  | 5.0 | Complete |  | COMPLETE | SI Test | Code Bodies | Systems Integration Testing (SIT) |  |  |  |  |  |
| 1162 | 1.4.1.4.5.1.3 | Industry Consultation |  | 10d | 2024-03-27 A | 2024-04-09 A | 1161 | 100% |  | 2024-03-27 | 2024-04-09 | 10d |  |  |  |  |  |  | SIT |  | 5.1 | Complete |  | COMPLETE | PP |  | Systems Integration Testing (SIT) |  |  |  |  |  |
| 1163 | 1.4.1.4.5.1.4 | Artefact review (via SITAG) and updates |  | 26d | 2024-04-10 A | 2024-05-15 A | 1162 | 100% |  | 2024-04-10 | 2024-05-15 | 30d | 2024-03-21 | 2024-05-15 |  |  |  |  | SIT |  | 5.0 | Complete |  | COMPLETE | SI Test | PP,IPA,Code Bodies | Systems Integration Testing (SIT) |  |  |  |  |  |
| 1164 | 1.4.1.4.5.1.5 | SIT Operational Testing Test Approach & Plan approved | milestone | 0d | 2024-05-15 A | 2024-05-15 A | 1163 | 100% |  | 2024-05-15 | 2024-05-15 | 0d | 2024-05-15 | 2024-05-15 |  |  |  |  | SIT |  | 5.24 | Complete |  | COMPLETE | SI Test | PP | Systems Integration Testing (SIT) | T3-TE-0029 | SITAG | T3 | MHHS-ART073 |  |
| 1165 | 1.4.1.4.5.2 | **Test Data Approach & Plan** |  | 36d | 2024-03-27 A | 2024-05-15 A |  | 100% |  | 2024-03-27 | 2024-05-15 | 36d | 2024-03-21 | 2024-05-15 |  |  |  | -0 | SIT |  | 5.0 |  | N/A |  | N/A | N/A | Systems Integration Testing (SIT) |  |  |  |  |  |
| 1166 | 1.4.1.4.5.2.1 | Industry Consultation |  | 10d | 2024-03-27 A | 2024-04-09 A | 1162SS | 100% |  | 2024-03-27 | 2024-04-09 | 10d |  |  |  |  |  |  | SIT |  | 5.1 | Complete | Richard Puddephatt | COMPLETE | PP |  | Systems Integration Testing (SIT) |  |  |  |  |  |
| 1167 | 1.4.1.4.5.2.2 | Artefact review (via SITAG) and updates |  | 26d | 2024-04-10 A | 2024-05-15 A | 1166 | 100% |  | 2024-04-10 | 2024-05-15 | 26d | 2024-03-21 | 2024-05-15 |  |  |  |  | SIT |  | 5.0 | Complete | Richard Puddephatt | COMPLETE | SI Test |  | Systems Integration Testing (SIT) |  |  |  |  |  |
| 1168 | 1.4.1.4.5.2.3 | SIT Operational Testing Test Data Approach & Plan approved | milestone | 0d | 2024-05-15 A | 2024-05-15 A | 1167 | 100% |  | 2024-05-15 | 2024-05-15 | 0d | 2024-05-15 | 2024-05-15 |  |  |  |  | SIT |  | 5.0 | Complete | Richard Puddephatt | COMPLETE | SI Test | PP,IPA | Systems Integration Testing (SIT) |  |  |  |  |  |
| 1169 | 1.4.1.4.5.3 | **Test scenarios & Test Cases** |  | 108d | 2024-04-10 A | 2024-09-06 A |  | 100% |  | 2024-04-10 | 2025-01-31 | 116d | 2023-07-24 | 2024-01-17 |  |  |  | -0 | SIT |  | 5.21 |  | Richard Puddephatt |  | N/A | N/A | Systems Integration Testing (SIT) |  |  |  |  |  |
| 1170 | 1.4.1.4.5.3.1 | **Theme 1** |  | 108d | 2024-04-10 A | 2024-09-06 A |  | 100% |  | 2024-04-10 | 2024-09-06 | 96d |  |  |  |  |  | -0 | SIT | -448.67 | 6.0 |  | Richard Puddephatt |  | N/A | N/A | Systems Integration Testing (SIT) |  |  |  |  |  |
| 1171 | 1.4.1.4.5.3.1.1 | Develop Test Scenarios & Test Cases |  | 53d | 2024-04-10 A | 2024-06-21 A | 1162 | 100% |  | 2024-04-10 | 2024-06-21 | 16d |  |  |  |  |  |  | SIT |  | 6.0 | Complete | Richard Puddephatt | COMPLETE | SI Test | SI Test, PP |  |  |  |  |  |  |
| 1172 | 1.4.1.4.5.3.1.2 | Industry Review Workshop |  | 1d | 2024-06-24 A | 2024-06-24 A | 1171 | 100% |  | 2024-06-24 | 2024-06-24 | 1d |  |  |  |  |  |  | SIT |  | 6.0 | Complete | Richard Puddephatt | COMPLETE | SI Test, PP | SI Test, PP |  |  |  |  |  |  |
| 1173 | 1.4.1.4.5.3.1.3 | Industry Consultation Review |  | 6d | 2024-07-02 A | 2024-07-09 A | 1172FS+17d | 100% |  | 2024-07-02 | 2024-07-09 | 6d |  |  |  |  |  |  | SIT |  | 6.0 | Complete | Richard Puddephatt | COMPLETE | SI Test, PP | SI Test, PP |  |  |  |  |  |  |
| 1174 | 1.4.1.4.5.3.1.4 | Review with SIT Working Group |  | 5d | 2024-08-19 A | 2024-08-23 A | 1173FS+16d | 100% |  | 2024-08-19 | 2024-08-23 | 5d |  |  |  |  |  |  | SIT |  | 6.0 | Complete | Richard Puddephatt | COMPLETE | SI Test, PP | SI Test, PP |  |  |  |  |  |  |
| 1175 | 1.4.1.4.5.3.1.5 | SIT Operational Scenarios & Test Cases Approved - Theme 1 | milestone | 0d | 2024-09-06 A | 2024-09-06 A | 1174FS+10d | 100% |  | 2024-09-06 | 2024-09-06 | 0d |  |  |  |  | start no earlier than 2024-09-06 |  | SIT |  | 6.0 | Complete | Richard Puddephatt | COMPLETE | SI Test | SI Test, PP | Systems Integration Testing (SIT) | T3-TE-0117 | SITAG |  |  | 31/7/24: baseline date change approved at esitag on 26/7/24 |
| 1176 | 1.4.1.4.5.3.2 | **Theme 2** |  | 107d | 2024-04-10 A | 2024-09-06 A |  | 100% |  | 2024-04-10 | 2024-09-06 | 71d |  |  |  |  |  |  | SIT | -448.67 | 6.0 |  | Richard Puddephatt |  | N/A | N/A | Systems Integration Testing (SIT) |  |  |  |  |  |
| 1177 | 1.4.1.4.5.3.2.1 | Develop Test Scenarios & Test Cases |  | 53d | 2024-04-10 A | 2024-06-21 A | 1162 | 100% |  | 2024-04-10 | 2024-06-21 | 31d |  |  |  |  | finish no earlier than 2024-06-21 |  | SIT |  | 6.0 | Complete | Richard Puddephatt | COMPLETE | SI Test | SI Test, PP |  |  |  |  |  |  |
| 1178 | 1.4.1.4.5.3.2.2 | Industry Review Workshop |  | 1d | 2024-06-24 A | 2024-06-24 A | 1177 | 100% |  | 2024-06-24 | 2024-06-24 | 1d |  |  |  |  |  |  | SIT |  | 6.0 | Complete | Richard Puddephatt | COMPLETE | SI Test, PP | SI Test, PP |  |  |  |  |  |  |
| 1179 | 1.4.1.4.5.3.2.3 | Industry Consultation Review |  | 6d | 2024-07-02 A | 2024-07-09 A | 1178FS+7d | 100% |  | 2024-07-02 | 2024-07-09 | 6d |  |  |  |  |  |  | SIT |  | 6.0 | Complete | Richard Puddephatt | COMPLETE | SI Test, PP | SI Test, PP |  |  |  |  |  |  |
| 1180 | 1.4.1.4.5.3.2.4 | Review with SIT Working Group |  | 5d | 2024-08-19 A | 2024-08-23 A | 1179FS+11d | 100% |  | 2024-08-19 | 2024-08-23 | 5d |  |  |  |  |  |  | SIT |  | 6.0 | Complete | Richard Puddephatt | COMPLETE | SI Test, PP | SI Test, PP |  |  |  |  |  |  |
| 1181 | 1.4.1.4.5.3.2.5 | SIT Operational Scenarios & Test Cases Approved - Theme 2 | milestone | 0d | 2024-09-06 A | 2024-09-06 A | 1180FS+10d | 100% |  | 2024-09-06 | 2024-09-06 | 0d |  |  |  |  |  |  | SIT |  | 6.0 | Complete | Richard Puddephatt | COMPLETE | SI Test | SI Test, PP | Systems Integration Testing (SIT) | T3-TE-0118 | SITAG |  |  |  |

Notes:
- 1153: 08/11/24 - Dates for this activity are being determined.
- 1154: 08/11/24 - Dates for this activity are being determined.
- 1155: 08/11/24 - Dates for this activity are being determined.
- 1156: 27/11/24 - Date amended to reflect updated NFT testing preparation approach. RAG at Amber because the predecessor 'SIT Non-Functional PIT Completion Report MHHS Review Complete' is running Amber.
- 1157: 27/11/24 - New activity created to reflect the updated NFT testing preparation approach. Milestone ID assigned which will go to SITAG to be approved.

| ID | WBS | Task | Type | Duration | Start | Finish | Predecessors | Complete | Remaining | Total slack | Free slack | Constraint | Text9 | Task Status | Update Version | Sched Status | MHHS Resource Name | RAG | Milestone ID |
| --- | --- | --- | --- | --- | --- | --- | --- | --- | --- | --- | --- | --- | --- | --- | --- | --- | --- | --- | --- |
| 1182 | 1.4.1.4.5.4 | **SIT Operations Manual** |  | 590d? | 2022-10-31 A | 2025-01-31 |  | 35% | 382.06d? | 754d |  |  | SIT | -755.67 | 6.13 | Overdue Start | Helix | RED |  |
| 1183 | 1.4.1.4.5.4.1 | **Version 1 SIT Operations Manual** |  | 35d | 2024-10-07 A | 2024-11-22 A |  | 100% |  |  |  |  | SIT | -755.67 | 6.13 | Overdue Start | Helix | RED |  |
| 1184 | 1.4.1.4.5.4.1.1 | Creation of SIT Operations Manual Template |  | 8d | 2024-10-07 A | 2024-10-16 A |  | 100% |  |  |  | start no earlier than 2024-10-07 | SIT |  | 6.13 | Complete | Helix | COMPLETE |  |
| 1185 | 1.4.1.4.5.4.1.2 | November TORWG Paper Day | milestone | 0d | 2024-11-07 A | 2024-11-07 A | 1184FS+16d | 100% |  |  |  |  | SIT |  | 6.13 | Complete | Helix | COMPLETE |  |
| 1186 | 1.4.1.4.5.4.1.3 | November TORWG (Timeline and Next Steps for SIT Operations Manual) | milestone | 0d | 2024-11-14 A | 2024-11-14 A | 1185FS+5d | 100% |  |  |  |  | SIT |  | 6.13 | Complete | Helix | COMPLETE |  |
| 1187 | 1.4.1.4.5.4.1.4 | SIT Operations Manual Version 1 Shared with MHHSP | milestone | 0d | 2024-11-11 A | 2024-11-11 A | 1184FS+18d | 100% |  |  |  |  | SIT |  | 6.13 | Complete | Helix | COMPLETE |  |
| 1188 | 1.4.1.4.5.4.1.5 | MHHSP provide feedback on SIT Operations Manual Version 1 |  | 9d | 2024-11-12 A | 2024-11-22 A | 1187 | 100% |  |  |  |  | SIT |  | 6.13 | Complete | Helix | COMPLETE |  |
| 1189 | 1.4.1.4.5.4.1.6 | SIT Operations Manual Version 1 Shared with Programme Participants | milestone | 0d | 2024-11-13 A | 2024-11-13 A | 1184FS+20d | 100% |  |  |  |  | SIT |  | 6.13 | Complete | Helix | COMPLETE |  |
| 1190 | 1.4.1.4.5.4.1.7 | PPs provide feedback on SIT Operations Manual Version 1 |  | 7d | 2024-11-14 A | 2024-11-22 A | 1189 | 100% |  |  |  |  | SIT |  | 6.13 | Complete | Helix | COMPLETE |  |
| 1191 | 1.4.1.4.5.4.1.8 | Programme Participants and MHHSP Feedback and Actions Received (SIT Ops Manual Version 1) | milestone | 0d | 2024-11-22 A | 2024-11-22 A | 1190, 1188 | 100% |  |  |  |  | SIT |  | 6.13 | Complete | Helix | COMPLETE |  |
| 1192 | 1.4.1.4.5.4.2 | **Version 2 SIT Operations Manual** |  | 27d | 2024-11-12 | 2024-12-18 |  |  |  | 757d |  |  | SIT | -755.67 | 6.13 | Overdue Start | Helix |  |  |
| 1193 | 1.4.1.4.5.4.2.1 | Version 2 SIT Operations Manual (Composition) |  | 12d | 2024-11-12 | 2024-11-27 | 1185FS+2d |  |  | 757d | 0d |  | SIT | -14.67 | 6.13 | No BL | Helix | GREEN |  |
| 1194 | 1.4.1.4.5.4.2.2 | Version 2 SIT Operations Manual Completed | milestone | 0d | 2024-11-27 | 2024-11-27 | 1193 |  |  | 757d | 0d |  | SIT | 0.71 | 6.13 | No BL | Helix | GREEN | T3-TE-0132 |
| 1195 | 1.4.1.4.5.4.2.3 | Version 2 SIT Operations Manual Shared with MHHSP & PPs for TORWG (Consultation Starts) | milestone | 0d | 2024-11-27 | 2024-11-27 | 1194 |  |  | 772d | 0d |  | SIT | 0.71 | 6.13 | No BL | Helix | GREEN |  |
| 1196 | 1.4.1.4.5.4.2.4 | Version 2 SIT Ops Manual - PP Consultation (Iterative Feedback Process) |  | 10d | 2024-11-28 | 2024-12-11 | 1195 |  |  | 772d | 0d |  | SIT | 1.33 | 6.13 | No BL | Helix | GREEN |  |
| 1197 | 1.4.1.4.5.4.2.5 | Version 2 SIT Ops Manual - PP Consultation Completed | milestone | 0d | 2024-12-11 | 2024-12-11 | 1196 |  |  | 772d | 0d |  | SIT | 14.71 | 6.13 | No BL | Helix | GREEN |  |
| 1198 | 1.4.1.4.5.4.2.6 | December TORWG Paper Day | milestone | 0d | 2024-12-04 | 2024-12-04 | 1193FS+5d |  |  | 791d | 0d |  | SIT | 7.71 | 6.13 | No BL | Helix | GREEN |  |
| 1199 | 1.4.1.4.5.4.2.7 | December TORWG (Initial Feedback, Common Themes and Comments) | milestone | 0d | 2024-12-11 | 2024-12-11 | 1198FS+5d |  |  | 791d |  |  | SIT | 14.71 | 6.13 | No BL | Helix | GREEN |  |
| 1200 | 1.4.1.4.5.4.2.8 | December Extraordinary TORWG Paper Day | milestone | 0d | 2024-12-11 | 2024-12-11 | 1197 |  |  | 772d | 0d |  | SIT | 14.71 | 6.13 | No BL | Helix | GREEN |  |
| 1201 | 1.4.1.4.5.4.2.9 | December Extraordinary TORWG (Summary of Version 2 Feedback and Response Approach Shared with PPs) | milestone | 0d | 2024-12-18 | 2024-12-18 | 1200FS+5d |  |  | 772d | 15d |  | SIT | 21.71 | 6.13 | No BL | Helix | GREEN |  |
| 1202 | 1.4.1.4.5.4.3 | **Version 3 (Final) SIT Operations Manual** |  | 44d | 2024-11-28 | 2025-01-28 |  |  |  | 757d |  |  | SIT | -755.67 | 6.13 | Overdue Start | Helix |  |  |
| 1203 | 1.4.1.4.5.4.3.1 | Update SIT Operations Manual (Final) Version 3 (with Comments Received From Version 2) [Pre-Christmas Furlough] |  | 17d | 2024-11-28 | 2024-12-20 | 1194, 173FF |  |  | 757d | 0d |  | SIT | 1.33 | 6.13 | No BL | Helix | GREEN |  |
| 1204 | 1.4.1.4.5.4.3.2 | Update SIT Operations Manual (Final) Version 3 (with Comments Received From Version 2) [Post-Christmas Furlough] |  | 5d | 2025-01-02 | 2025-01-08 | 1203FS+8d, 1201FF |  |  | 757d | 0d |  | SIT | 36.33 | 6.13 | No BL | Helix | GREEN |  |
| 1205 | 1.4.1.4.5.4.3.3 | SIT Operations Manual (Final) Version 3 Completed | milestone | 0d | 2025-01-08 | 2025-01-08 | 1204 |  |  | 757d | 0d |  | SIT | 42.71 | 6.13 | No BL | Helix | GREEN | T3-TE-0133 |
| 1206 | 1.4.1.4.5.4.3.4 | January TORWG Paper Day | milestone | 0d | 2025-01-08 | 2025-01-08 | 1205 |  |  | 757d | 0d |  | SIT | 42.71 | 6.13 | No BL | Helix | GREEN |  |
| 1207 | 1.4.1.4.5.4.3.5 | January TORWG (SIT Operations Manual Agreement) [Assurance Meeting] | milestone | 0d | 2025-01-15 | 2025-01-15 | 1206FS+5d |  |  | 757d | 0d |  | SIT | 49.71 | 6.13 | No BL | Helix | GREEN |  |
| 1208 | 1.4.1.4.5.4.3.6 | January MCAG Paper Day (Final SIT Operations Manual Submitted) | milestone | 0d | 2025-01-21 | 2025-01-21 | 1207FS+4d |  |  | 757d | 0d |  | SIT | 55.71 | 6.13 | No BL | Helix | GREEN |  |
| 1209 | 1.4.1.4.5.4.3.7 | January MCAG (Final SIT Operations Manual Endorsement) [Advisory Group Sign-off] | milestone | 0d | 2025-01-28 | 2025-01-28 | 1208FS+5d |  |  | 757d |  |  | SIT | 62.71 | 6.13 | No BL | Helix | GREEN | T3-TE-0135 |

Notes:
- 1194: 27/11/24 - New milestone added by Programme, awaiting formal SITAG approval.
- 1205: 27/11/24 - New milestone added by Programme, awaiting formal SITAG approval.
- 1209: 27/11/24 - New milestone added by Programme, awaiting formal SITAG approval.

| ID | WBS | Task | Type | Duration | Start | Finish | Predecessors | Complete | Remaining | Actual start | Actual finish | Baseline start | Baseline finish | Baseline duration | Total slack | Free slack | Constraint | Responsible | Text9 | Task Status | Update Version | Sched Status | MHHS Resource Name | RAG |
| --- | --- | --- | --- | --- | --- | --- | --- | --- | --- | --- | --- | --- | --- | --- | --- | --- | --- | --- | --- | --- | --- | --- | --- | --- |
| 1210 | 1.4.1.4.5.4.4 | **Elexon / Helix Service Management Test Prep** |  | 119d? | 2024-08-01 A | 2025-01-14 |  | 27% | 86.72d? |  |  | 2024-07-15 | 2025-01-31 | 0d | 129d |  |  | Helix | SIT | -688.67 | 6.13 | Overdue Start | Helix |  |
| 1211 | 1.4.1.4.5.4.4.1 | **Incident Management Build** |  | 75d? | 2024-08-05 A | 2024-11-15 A |  | 100% |  |  |  | 2024-08-05 | 2024-11-15 | 0d |  |  |  | Helix | SIT | -728.67 | 6.13 | Overdue Start | Helix |  |
| 1212 | 1.4.1.4.5.4.4.1.1 | Build |  | 40d | 2024-08-05 A | 2024-09-27 A |  | 100% |  |  |  | 2024-09-27 | 2024-09-27 | 0d |  |  | finish no earlier than 2024-09-27 | Helix | SIT |  | 6.13 | Complete | Helix | COMPLETE |
| 1213 | 1.4.1.4.5.4.4.1.2 | Test |  | 15d | 2024-09-30 A | 2024-10-18 A | 1212 | 100% |  |  |  | 2024-10-18 | 2024-10-18 | 0d |  |  | finish no earlier than 2024-10-18 | Helix | SIT |  | 6.13 | Complete | Helix | COMPLETE |
| 1214 | 1.4.1.4.5.4.4.1.3 | Deploy |  | 20d | 2024-10-21 A | 2024-11-15 A | 1213 | 100% |  |  |  | 2024-11-15 | 2024-11-15 | 0d |  |  | finish no earlier than 2024-11-15 | Helix | SIT |  | 6.13 | Complete | Helix | COMPLETE |
| 1215 | 1.4.1.4.5.4.4.1.4 | Incident Management Build & Configuration Complete | milestone | 0d | 2024-11-15 A | 2024-11-15 A | 1214 | 100% |  |  |  |  |  |  |  |  |  | Helix | SIT |  | 6.13 | Complete | Helix | COMPLETE |
| 1216 | 1.4.1.4.5.4.4.2 | **Major Incident Management Build & Configuration** |  | 0d? | 2024-11-15 | 2024-11-15 |  | 100% |  | 2024-10-02 | 2025-01-14 | 2024-10-02 | 2025-01-14 | 0d |  |  |  | Helix | SIT | -728.67 | 6.13 | Overdue Start | Helix |  |
| 1217 | 1.4.1.4.5.4.4.2.1 | Build |  | 40d | 2024-10-02 A | 2024-11-26 A |  | 100% |  |  |  | 2024-11-26 | 2024-11-26 | 0d |  |  | finish no earlier than 2024-11-26 | Helix | SIT |  | 6.13 | Complete | Helix | COMPLETE |
| 1218 | 1.4.1.4.5.4.4.2.2 | Test |  | 15d | 2024-11-27 A | 2024-12-17 A | 1217 | 100% |  |  |  | 2024-12-17 | 2024-12-17 | 0d |  |  | finish no earlier than 2024-12-17 | Helix | SIT |  | 6.13 | Complete | Helix | COMPLETE |
| 1219 | 1.4.1.4.5.4.4.2.3 | Deploy |  | 20d | 2024-12-18 A | 2025-01-14 A | 1218 | 100% |  |  |  | 2025-01-14 | 2025-01-14 | 0d |  |  | finish no earlier than 2025-01-14 | Helix | SIT |  | 6.13 | Complete | Helix | COMPLETE |
| 1220 | 1.4.1.4.5.4.4.2.4 | Major Incident Management Build & Configuration Complete | milestone | 0d | 2025-01-14 A | 2025-01-14 A | 1219 | 100% |  |  |  |  |  |  |  |  |  | Helix | SIT |  | 6.13 | Complete | Helix | COMPLETE |
| 1221 | 1.4.1.4.5.4.4.3 | **Knowledge Management Build & Configuration** |  | 75d? | 2024-10-02 | 2025-01-14 |  |  |  |  |  | 2024-10-02 | 2025-01-14 | 0d |  |  |  | Helix | SIT | -728.67 | 6.13 | Overdue Start | Helix |  |
| 1222 | 1.4.1.4.5.4.4.3.1 | Build |  | 40d | 2024-10-02 | 2024-11-26 |  |  |  |  |  | 2024-11-26 | 2024-11-26 | 0d | 129d | 0d | finish no earlier than 2024-11-26 | Helix | SIT | -55.67 | 6.13 | Overdue Start | Helix | GREEN |
| 1223 | 1.4.1.4.5.4.4.3.2 | Test |  | 15d | 2024-11-27 | 2024-12-17 | 1222 |  |  |  |  | 2024-12-17 | 2024-12-17 | 0d | 129d | 0d | finish no earlier than 2024-12-17 | Helix | SIT | 0.33 | 6.13 | Green | Helix | GREEN |
| 1224 | 1.4.1.4.5.4.4.3.3 | Deploy |  | 20d | 2024-12-18 | 2025-01-14 | 1223 |  |  |  |  | 2025-01-14 | 2025-01-14 | 0d | 129d | 0d | finish no earlier than 2025-01-14 | Helix | SIT | 21.33 | 6.13 | Green | Helix | GREEN |
| 1225 | 1.4.1.4.5.4.4.3.4 | Knowledge Management Build & Configuration Complete | milestone | 0d | 2025-01-14 | 2025-01-14 | 1224 |  |  |  |  |  |  |  | 129d | 0d |  | Helix | SIT | 48.71 | 6.13 | No BL | Helix | GREEN |
| 1226 | 1.4.1.4.5.4.4.4 | **Problem Management Build Build & Configuration** |  | 1d? | 2024-08-01 | 2024-08-01 |  |  |  |  |  | 2024-10-02 | 2025-01-14 | 0d |  |  |  | Helix | SIT | -728.67 | 6.13 | Overdue Start | Helix |  |
| 1227 | 1.4.1.4.5.4.4.4.1 | Build |  | 40d | 2024-10-02 | 2024-11-26 |  |  |  |  |  | 2024-11-26 | 2024-11-26 | 0d | 129d | 0d | finish no earlier than 2024-11-26 | Helix | SIT | -55.67 | 6.13 | Overdue Start | Helix | GREEN |
| 1228 | 1.4.1.4.5.4.4.4.2 | Test |  | 15d | 2024-11-27 | 2024-12-17 | 1227 |  |  |  |  | 2024-12-17 | 2024-12-17 | 0d | 129d | 0d | finish no earlier than 2024-12-17 | Helix | SIT | 0.33 | 6.13 | Green | Helix | GREEN |
| 1229 | 1.4.1.4.5.4.4.4.3 | Deploy |  | 20d | 2024-12-18 | 2025-01-14 | 1228 |  |  |  |  | 2025-01-14 | 2025-01-14 | 0d | 129d | 0d | finish no earlier than 2025-01-14 | Helix | SIT | 21.33 | 6.13 | Green | Helix | GREEN |
| 1230 | 1.4.1.4.5.4.4.4.4 | Problem Management Build & Configuration Complete | milestone | 0d | 2025-01-14 | 2025-01-14 | 1229 |  |  |  |  |  |  |  | 129d | 0d | start no earlier than 2025-01-14 | Helix | SIT | 48.71 | 6.13 | No BL | Helix | GREEN |
| 1231 | 1.4.1.4.5.4.4.5 | **Change Management Build & Configuration** |  | 75d? | 2024-10-02 | 2025-01-14 |  |  |  |  |  | 2024-10-02 | 2025-01-14 | 0d |  |  |  | Helix | SIT | -728.67 | 6.13 | Overdue Start | Helix |  |
| 1232 | 1.4.1.4.5.4.4.5.1 | Build |  | 40d | 2024-10-02 | 2024-11-26 |  |  |  |  |  | 2024-11-26 | 2024-11-26 | 0d | 129d | 0d | finish no earlier than 2024-11-26 | Helix | SIT | -55.67 | 6.13 | Overdue Start | Helix | GREEN |
| 1233 | 1.4.1.4.5.4.4.5.2 | Test |  | 15d | 2024-11-27 | 2024-12-17 | 1232 |  |  |  |  | 2024-12-17 | 2024-12-17 | 0d | 129d | 0d | finish no earlier than 2024-12-17 | Helix | SIT | 0.33 | 6.13 | Green | Helix | GREEN |
| 1234 | 1.4.1.4.5.4.4.5.3 | Deploy |  | 20d | 2024-12-18 | 2025-01-14 | 1233 |  |  |  |  | 2025-01-14 | 2025-01-14 | 0d | 129d | 0d | finish no earlier than 2025-01-14 | Helix | SIT | 21.33 | 6.13 | Green | Helix | GREEN |
| 1235 | 1.4.1.4.5.4.4.5.4 | Change Management Build & Configuration Complete | milestone | 0d | 2025-01-14 | 2025-01-14 | 1234 |  |  |  |  |  |  |  | 129d | 0d | start no earlier than 2025-01-14 | Helix | SIT | 48.71 | 6.13 | No BL | Helix | GREEN |

| ID | WBS | Task | Type | Duration | Start | Finish | Predecessors | Complete | Remaining | Baseline start | Baseline finish | Baseline duration | Total slack | Free slack | Constraint | Responsible | Text9 | Task Status | Update Version | Sched Status | MHHS Resource Name | RAG | Milestone ID |
| --- | --- | --- | --- | --- | --- | --- | --- | --- | --- | --- | --- | --- | --- | --- | --- | --- | --- | --- | --- | --- | --- | --- | --- |
| 1236 | 1.4.1.4.5.4.4.6 | **Service Catalogue Management Build & Configuration** |  | 75d? | 2024-10-02 | 2025-01-14 |  |  |  | 2024-10-02 | 2025-01-14 | 0d |  |  |  | Helix | SIT | -728.67 | 6.13 | Overdue Start | Helix |  |  |
| 1237 | 1.4.1.4.5.4.4.6.1 | Build |  | 40d | 2024-10-02 | 2024-11-26 |  |  |  | 2024-11-26 | 2024-11-26 | 0d | 129d | 0d | finish no earlier than 2024-11-26 | Helix | SIT | -55.67 | 6.13 | Overdue Start | Helix | GREEN |  |
| 1238 | 1.4.1.4.5.4.4.6.2 | Test |  | 15d | 2024-11-27 | 2024-12-17 | 1237 |  |  | 2024-12-17 | 2024-12-17 | 0d | 129d | 0d | finish no earlier than 2024-12-17 | Helix | SIT | 0.33 | 6.13 | Green | Helix | GREEN |  |
| 1239 | 1.4.1.4.5.4.4.6.3 | Deploy |  | 20d | 2024-12-18 | 2025-01-14 | 1238 |  |  | 2025-01-14 | 2025-01-14 | 0d | 129d | 0d | finish no earlier than 2025-01-14 | Helix | SIT | 21.33 | 6.13 | Green | Helix | GREEN |  |
| 1240 | 1.4.1.4.5.4.4.6.4 | Service Catalogue Management Build & Configuration Complete | milestone | 0d | 2025-01-14 | 2025-01-14 | 1239 |  |  |  |  |  | 129d | 0d | start no earlier than 2025-01-14 | Helix | SIT | 48.71 | 6.13 | No BL | Helix | GREEN |  |
| 1241 | 1.4.1.4.5.4.4.7 | ServiceNow SIT Ops Available | milestone | 0d? | 2025-01-14 | 2025-01-14 | 1215, 1220, 1225, 1230, 1235, 1240 |  |  | 2025-01-14 | 2025-01-14 | 0d | 129d | 13d | start no earlier than 2024-09-09 | Helix | SIT | 48.71 | 6.13 | Green | Helix | GREEN | T3-TE-0136 |
| 1242 | 1.4.1.4.5.4.4.8 | **Helix Service Management Documentation (Service Design Pack)** |  | 102d | 2024-08-01 | 2024-12-20 |  |  |  | 2024-09-09 | 2025-01-31 | 0d | 146d | 30d |  | Helix | SIT | -49.67 | 6.0 | Overdue Start | Helix |  |  |
| 1243 | 1.4.1.4.5.4.4.8.1 | Document Drafting |  | 95d | 2024-08-01 | 2024-12-11 |  |  |  | 2024-08-01 | 2024-12-11 | 0d | 150d | 0d | finish no earlier than 2024-12-11 | Helix | SIT | -117.67 | 6.11 | Overdue Start | Helix | GREEN |  |
| 1244 | 1.4.1.4.5.4.4.8.2 | Internal Elexon Review |  | 3d | 2024-12-12 | 2024-12-16 | 1243 |  |  | 2024-12-12 | 2024-12-16 | 0d | 150d |  | finish no earlier than 2024-12-16 | Helix | SIT | 15.33 | 6.11 | Green | Helix | GREEN |  |
| 1245 | 1.4.1.4.5.4.4.8.3 | Elexon Service Panel Review |  | 5d | 2024-12-16 | 2024-12-20 |  |  |  | 2024-12-16 | 2024-12-20 | 0d | 146d | 0d | finish no earlier than 2024-12-20 | Helix | SIT | 19.33 | 6.11 | Green | Helix | GREEN |  |
| 1246 | 1.4.1.4.5.4.4.8.4 | Elexon Service Panel Sign off | milestone | 0d | 2024-12-20 | 2024-12-20 | 1245 |  |  | 2024-12-20 | 2024-12-20 | 0d | 146d |  | start no earlier than 2024-12-20 | Helix | SIT | 23.71 | 6.11 | Green | Helix | GREEN |  |
| 1247 | 1.4.1.4.5.4.5 | **Incident Management Support** |  | 1d? | 2022-10-31 | 2022-10-31 |  |  |  |  |  |  |  |  |  | Helix | SIT | -755.67 | 6.13 | Overdue Start | Helix | 25d |  |
| 1248 | 1.4.1.4.5.4.5.1 | Identify Relevant Stakeholders to Support Incident Management Process |  | 10d | 2024-11-18 | 2024-11-29 |  |  |  |  |  |  | 784d | 0d | start no earlier than 2024-11-18 | Helix | SIT | -8.67 | 6.13 | No BL | Helix | GREEN |  |
| 1249 | 1.4.1.4.5.4.5.2 | Schedule Time to Upskill Stakeholders |  | 5d | 2024-12-02 | 2024-12-06 | 1248 |  |  |  |  |  | 784d | 0d |  | Helix | SIT | 5.33 | 6.13 | No BL | Helix | GREEN |  |
| 1250 | 1.4.1.4.5.4.5.3 | Helix Stakeholders Attendance at MHHS Defect Triage Meetings [Meeting Dates to be Confirmed] |  | 10d | 2024-12-09 | 2024-12-20 | 1249 |  |  |  |  |  | 784d | 0d |  | Helix | SIT | 12.33 | 6.13 | No BL | Helix | GREEN |  |
| 1251 | 1.4.1.4.5.4.6 | SIT Service Readiness (Elexon & Helix) Completed | milestone | 0d | 2024-12-20 | 2024-12-20 | 1250 |  |  |  |  |  | 784d |  |  | Helix | SIT | 23.71 | 6.13 | No BL | Helix | GREEN |  |
| 1252 | 1.4.1.4.5.4.7 | **SIT Service Readiness (External Parties)** |  | 71d? | 2024-09-30 | 2025-01-06 |  |  |  |  |  |  | 773d |  |  | Helix | SIT | -755.67 | 6.13 | Overdue Start | Helix | RED |  |
| 1253 | 1.4.1.4.5.4.7.1 | Helix Engagement & Comms |  | 71d | 2024-09-30 | 2025-01-06 |  |  |  |  |  |  | 773d | 0d | start no earlier than 2024-09-30 | Helix | SIT | -57.67 | 6.13 | Overdue Start | Helix | GREEN |  |
| 1254 | 1.4.1.4.5.4.7.2 | Engagement Execution |  | 66d | 2024-10-07 | 2025-01-06 |  |  |  |  |  |  | 773d | 0d | start no earlier than 2024-10-07 | Helix | SIT | -50.67 | 6.13 | Overdue Start | Helix | GREEN |  |
| 1255 | 1.4.1.4.5.4.7.3 | Information Gathering |  | 20d? | 2024-10-31 | 2024-11-27 |  |  |  |  |  |  | 801d | 28d | start no earlier than 2024-10-31 | Helix | SIT | -26.67 | 6.13 | No BL | Helix | GREEN |  |
| 1256 | 1.4.1.4.5.4.7.4 | SIT Participants Preparation |  | 32d | 2024-11-22 | 2025-01-06 |  |  |  |  |  |  | 773d | 0d | start no earlier than 2024-11-22 | Helix | SIT | -4.67 | 6.13 | No BL | Helix | GREEN |  |
| 1257 | 1.4.1.4.5.4.7.5 | SIT Service Readiness (Externak Parties) Completed | milestone | 0d | 2025-01-06 | 2025-01-06 | 1253, 1254, 1255, 1256 |  |  |  |  |  | 773d |  |  | Helix | SIT | 40.71 | 6.13 | No BL | Helix | GREEN |  |
| 1258 | 1.4.1.4.5.4.8 | **ServiceNow Support Portal Onboarding (Helix Suppliers & SIT Participants)** |  | 78d? | 2024-10-02 A | 2025-01-17 |  | 27% | 56.73d? |  |  |  |  |  |  | Helix | SIT | -755.67 | 6.13 | Overdue Start | Helix | RED |  |
| 1259 | 1.4.1.4.5.4.8.1 | **ServiceNow Portal Preparation and Planning** |  | 40d? | 2024-10-02 A | 2024-11-26 |  | 50% | 20d? |  |  |  |  |  |  | Helix | SIT | -755.67 | 6.13 | Overdue Start | Helix | RED |  |
| 1260 | 1.4.1.4.5.4.8.1.1 | Define Supplier Requirements |  | 30d? | 2024-10-02 A | 2024-11-12 A |  | 100% |  |  |  |  |  |  | start no earlier than 2024-10-02 | Helix | SIT |  | 6.13 | Complete | Helix | COMPLETE |  |
| 1261 | 1.4.1.4.5.4.8.1.2 | Determine Supplier ServiceNow modules |  | 10d? | 2024-11-13 | 2024-11-26 | 1260 |  |  |  |  |  | 802d |  | finish no earlier than 2024-11-26 | Helix | SIT | -13.67 | 6.13 | No BL | Helix | GREEN |  |
| 1262 | 1.4.1.4.5.4.8.1.3 | Review compliance requirements, including data privacy and access limitations. |  | 10d? | 2024-11-13 | 2024-11-26 | 1260 |  |  |  |  |  | 802d |  | finish no earlier than 2024-11-26 | Helix | SIT | -13.67 | 6.13 | No BL | Helix | GREEN |  |
| 1263 | 1.4.1.4.5.4.8.1.4 | Conduct a security assessment to ensure the supplier complies with organisational policies. |  | 10d? | 2024-11-13 | 2024-11-26 | 1260 |  |  |  |  |  | 772d | 0d | finish no earlier than 2024-11-26 | Helix | SIT | -13.67 | 6.13 | No BL | Helix | GREEN |  |

Notes:
- 1241: 27/11/24 - New milestone added by Programme, awaiting formal SITAG approval.
- 1256: Notes (2): Add in dependency between Operations Manual and PP prep as per their feedback on the Test Cases.

| ID | WBS | Task | Type | Duration | Start | Finish | Predecessors | Complete | Remaining | Baseline start | Baseline finish | Baseline duration | Total slack | Free slack | Constraint | Baseline cost | Responsible | Text9 | Task Status | Update Version | Sched Status | MHHS Resource Name | RAG | Milestone ID | Involved | MHHS Programme Phase |
| --- | --- | --- | --- | --- | --- | --- | --- | --- | --- | --- | --- | --- | --- | --- | --- | --- | --- | --- | --- | --- | --- | --- | --- | --- | --- | --- |
| 1264 | 1.4.1.4.5.4.8.2 | **ServiceNow Portal System Configuration** |  | 30d? | 2024-11-27 | 2025-01-07 |  |  |  |  |  |  |  |  |  |  | Helix | SIT | -755.67 | 6.13 | Overdue Start | Helix | RED |  |  |  |
| 1265 | 1.4.1.4.5.4.8.2.1 | Create Supplier User Accounts |  | 10d? | 2024-11-27 | 2024-12-10 | 1263 |  |  |  |  |  | 772d | 0d | finish no earlier than 2024-12-10 |  | Helix | SIT | 0.33 | 6.13 | No BL | Helix | GREEN |  |  |  |
| 1266 | 1.4.1.4.5.4.8.2.2 | Assign appropriate access based on the supplier’s needs and security requirements (e.g., read-only access, submit requests, etc.). |  | 10d? | 2024-12-11 | 2024-12-24 | 1265 |  |  |  |  |  | 772d | 0d | finish no earlier than 2024-12-24 |  | Helix | SIT | 14.33 | 6.13 | No BL | Helix | GREEN |  |  |  |
| 1267 | 1.4.1.4.5.4.8.2.3 | Configure Access Controls |  | 10d? | 2024-12-25 | 2025-01-07 | 1266 |  |  |  |  |  | 772d | 8d | finish no earlier than 2025-01-07 |  | Helix | SIT | 28.33 | 6.13 | No BL | Helix | GREEN |  |  |  |
| 1268 | 1.4.1.4.5.4.8.3 | **ServiceNow Portal Training and Documentation** |  | 5d? | 2025-01-06 | 2025-01-10 |  |  |  |  |  |  |  |  |  |  | Helix | SIT | -755.67 | 6.13 | Overdue Start | Helix | RED |  |  |  |
| 1269 | 1.4.1.4.5.4.8.3.1 | Provide Training to the Supplier |  | 5d | 2025-01-06 | 2025-01-10 |  |  |  |  |  |  | 764d | 0d | finish no earlier than 2025-01-10 |  | Helix | SIT | 40.33 | 6.13 | No BL | Helix | GREEN |  |  |  |
| 1270 | 1.4.1.4.5.4.8.3.2 | Create Supplier Training Documentation |  | 5d | 2025-01-06 | 2025-01-10 |  |  |  |  |  |  | 769d | 5d | finish no earlier than 2025-01-10 |  | Helix | SIT | 40.33 | 6.13 | No BL | Helix | GREEN |  |  |  |
| 1271 | 1.4.1.4.5.4.8.4 | **ServiceNow Portal Testing and Validation** |  | 8d? | 2025-01-08 | 2025-01-17 |  |  |  |  |  |  |  |  |  |  | Helix | SIT | -755.67 | 6.13 | Overdue Start | Helix | RED |  |  |  |
| 1272 | 1.4.1.4.5.4.8.4.1 | Conduct User Acceptance Testing (UAT) |  | 5d | 2025-01-13 | 2025-01-17 | 1269 |  |  |  |  |  | 764d |  | finish no earlier than 2025-01-17 |  | Helix | SIT | 47.33 | 6.13 | No BL | Helix | GREEN |  |  |  |
| 1273 | 1.4.1.4.5.4.8.4.2 | Validate Access and Security Controls |  | 5d | 2025-01-13 | 2025-01-17 | 1269 |  |  |  |  |  | 764d | 0d | finish no earlier than 2025-01-14 |  | Helix | SIT | 47.33 | 6.13 | No BL | Helix | GREEN |  |  |  |
| 1274 | 1.4.1.4.5.4.8.5 | ServiceNow Support Portal Onboarding (Helix Suppliers& SIT Participants) Completed | milestone | 0d | 2025-01-17 | 2025-01-17 | 1263, 1267, 1270, 1273 |  |  |  |  |  | 764d | 0d | start no earlier than 2025-01-17 |  | Helix | SIT | 51.71 | 6.13 | No BL | Helix | GREEN |  |  |  |
| 1275 | 1.4.1.4.5.4.9 | SIT Operational Readiness Report Completed | milestone | 0d | 2025-01-17 | 2025-01-17 | 1274 |  |  |  |  |  | 764d |  | start no earlier than 2025-01-17 |  | Helix | SIT | 51.71 | 6.13 | No BL | Helix | GREEN |  |  |  |
| 1276 | 1.4.1.4.5.4.10 | Stage 1 - Helix SIT Operational Readiness Completed |  | 1d? | 2025-01-31 | 2025-01-31 |  |  |  |  |  |  | 754d |  | start no earlier than 2025-01-31 |  | Helix | SIT | 65.33 | 6.13 | No BL | Helix | GREEN | T3-TE-0137 |  |  |
| 1277 | 1.4.1.4.5.4.11 | **Theme 3 (Batch 2)** |  | 65d | 2024-09-19 A | 2024-12-18 |  | 88% | 7.74d | 2024-09-19 | 2024-12-11 | 116d | 8.8d |  |  | -0 | N/A | SIT | -448.67 | 6.0 |  | Steve Evans |  |  | N/A | Systems Integration Testing (SIT) |
| 1278 | 1.4.1.4.5.4.11.1 | Conclude BCDR Scope with SRO, Code Bodies and DIP Manager |  | 22d | 2024-09-19 A | 2024-10-18 A |  | 100% |  | 2024-09-19 | 2024-10-18 | 0d |  |  | start no earlier than 2024-09-19 |  |  | SIT |  | 6.0 | Complete | Steve Evans | COMPLETE |  |  |  |
| 1279 | 1.4.1.4.5.4.11.2 | Develop BDCR Test Scenarios & Test Cases (Batch 2) |  | 10d | 2024-10-14 A | 2024-10-25 A | 1278 | 100% |  | 2024-10-14 | 2024-10-25 | 0d |  |  |  |  |  | SIT |  | 6.0 | Complete | Steve Evans | COMPLETE |  |  |  |
| 1280 | 1.4.1.4.5.4.11.3 | Develop DIP Test Scenarios and Test Cases (Batch 2) |  | 27d | 2024-09-19 A | 2024-10-25 A |  | 100% |  | 2024-09-19 | 2024-10-25 | 0d |  |  | start no earlier than 2024-09-19 |  |  | SIT |  | 6.0 | Complete | Steve Evans | COMPLETE |  |  |  |
| 1281 | 1.4.1.4.5.4.11.4 | SRO Review |  | 5d | 2024-10-28 A | 2024-11-01 A | 1280 | 100% |  | 2024-10-28 | 2024-11-01 | 0d |  |  | start no earlier than 2024-10-28 |  |  | SIT |  | 6.0 | Complete | Steve Evans | COMPLETE |  |  |  |
| 1282 | 1.4.1.4.5.4.11.5 | Industry Consultation (Batch 2) |  | 10d | 2024-11-11 A | 2024-11-22 A | 1281 | 100% |  | 2024-11-11 | 2024-11-22 | 1d |  |  |  |  | SI Test, PP | SIT |  | 6.0 | Complete | Steve Evans | COMPLETE |  | SI Test, PP |  |
| 1283 | 1.4.1.4.5.4.11.6 | Review Feedback and Update |  | 4d | 2024-11-25 | 2024-11-28 | 1282 |  |  | 2024-11-25 | 2024-11-29 | 0d | 8.8d | 0d |  |  | SI Test | SIT | -1.67 | 6.13 | Green | Steve Evans | GREEN |  |  |  |
| 1284 | 1.4.1.4.5.4.11.7 | SITWG paper day | milestone | 0d | 2024-11-28 | 2024-11-28 | 1283 |  |  |  |  |  | 8.8d | 0d |  |  |  | SIT | 1.71 | 6.13 | No BL | Steve Evans | GREEN |  |  |  |
| 1285 | 1.4.1.4.5.4.11.8 | Review with SIT WG (Batch 2) |  | 5d | 2024-11-29 | 2024-12-05 | 1284 |  |  | 2024-12-05 | 2024-12-12 | 0d | 8.8d | 0d |  |  | SI Test | SIT | 2.33 | 6.13 | Green | Steve Evans | GREEN |  |  |  |
| 1286 | 1.4.1.4.5.4.11.9 | SITWG endorse Theme 3 (Batch 2) | milestone | 0d | 2024-12-05 | 2024-12-05 | 1285 |  |  |  |  |  | 8.8d | 0d |  |  |  | SIT | 8.71 | 6.13 | No BL | Steve Evans | GREEN |  |  |  |
| 1287 | 1.4.1.4.5.4.11.10 | SITAG paper day | milestone | 0d | 2024-12-11 | 2024-12-11 | 1286FS+4d |  |  |  |  |  | 8.8d | 0d |  |  |  | SIT | 14.71 | 6.13 | No BL | Steve Evans | GREEN |  |  |  |
| 1288 | 1.4.1.4.5.4.11.11 | SITAG approve Theme 3 (Batch 2) |  | 1d | 2024-12-18 | 2024-12-18 | 1287FS+4d |  |  | 2024-12-18 | 2024-12-18 | 0d | 8.8d | 0d |  |  | SI Test | SIT | 21.33 | 6.13 | Green | Steve Evans | GREEN | T3-TE-0138 |  |  |

Notes:
- 1276: 27/11/24 - New milestone added by Programme, awaiting formal SITAG approval.
- 1279: 12/09/24 - Added new milestone for Batch 2
- 1281: 06/11/24 - SRO Review and Industry Workshop have both been moved to alleviate concurrent review with Batch 1.
- 1282: 12/09/24 - Forecast date changed in line with SI Plan.
- 1288: 27/11/24 - New milestone added by Programme, awaiting formal SITAG approval.

| ID | WBS | Task | Type | Duration | Start | Finish | Predecessors | Complete | Remaining | Baseline start | Baseline finish | Baseline duration | Total slack | Free slack | Constraint | Responsible | Text9 | Task Status | Update Version | Sched Status | MHHS Resource Name | Involved | RAG | Milestone ID | Guidance | MHHS Programme Phase | Text29 |
| --- | --- | --- | --- | --- | --- | --- | --- | --- | --- | --- | --- | --- | --- | --- | --- | --- | --- | --- | --- | --- | --- | --- | --- | --- | --- | --- | --- |
| 1289 | 1.4.1.4.5.4.12 | **Theme 3 (Batch 1)** |  | 181d? | 2024-04-10 A | 2024-12-18 |  | 96% | 6.51d? | 2024-04-10 | 2024-12-11 | 0d | 8.8d |  |  | SI Test | SIT | -688.67 | 6.0 | Overdue Start | Steve Evans |  |  |  |  |  |  |
| 1290 | 1.4.1.4.5.4.12.1 | Develop Test Scenarios & Test Cases (Batch 1) |  | 78d | 2024-04-10 A | 2024-07-26 A | 1162 | 100% |  | 2024-04-10 | 2024-07-26 | 46d |  |  |  | SI Test | SIT |  | 6.0 | Complete | Steve Evans | SI Test, PP | COMPLETE |  |  |  |  |
| 1291 | 1.4.1.4.5.4.12.2 | Conclude Industry Consultation (Batch 1) |  | 11d | 2024-09-05 A | 2024-09-19 A |  | 100% |  | 2024-09-05 | 2024-09-19 | 0d |  |  | start no earlier than 2024-09-05 | SI Test | SIT |  | 6.0 | Complete | Steve Evans |  | COMPLETE |  |  |  |  |
| 1292 | 1.4.1.4.5.4.12.3 | Review Feedback and Update |  | 5d | 2024-09-20 A | 2024-09-26 A | 1291 | 100% |  | 2024-09-20 | 2024-09-26 | 0d |  |  |  | SI Test | SIT |  | 6.0 | Complete | Steve Evans |  | COMPLETE |  |  |  |  |
| 1293 | 1.4.1.4.5.4.12.4 | Draft Test Cases from Feedback and LLSD |  | 15d? | 2024-09-30 A | 2024-10-18 A | 1292FS+1d, 1305 | 100% |  | 2024-09-30 | 2024-10-18 | 0d |  |  |  | SI Test | SIT |  | 6.0 | Complete | Steve Evans |  | COMPLETE |  |  |  |  |
| 1294 | 1.4.1.4.5.4.12.5 | SRO Review |  | 5d? | 2024-10-21 A | 2024-10-25 A | 1293 | 100% |  | 2024-10-21 | 2024-10-25 | 0d |  |  |  | SI Test | SIT |  | 6.0 | Complete | Steve Evans |  | COMPLETE |  |  |  |  |
| 1295 | 1.4.1.4.5.4.12.6 | Industry Consultation |  | 10d? | 2024-10-28 A | 2024-11-08 A | 1294 | 100% |  | 2024-10-28 | 2024-11-08 | 0d |  |  |  | SI Test | SIT |  | 6.0 | Complete | Steve Evans |  | COMPLETE |  |  |  |  |
| 1296 | 1.4.1.4.5.4.12.7 | Review Feedback and Update |  | 10d | 2024-11-11 A | 2024-11-22 A | 1295 | 100% |  | 2024-11-11 | 2024-11-15 | 0d |  |  |  | SI Test | SIT |  | 6.0 | Complete | Steve Evans |  | COMPLETE |  |  |  |  |
| 1297 | 1.4.1.4.5.4.12.8 | SITWG paper day | milestone | 0d | 2024-11-28 | 2024-11-28 | 1296FS+4d |  |  |  |  |  | 9.8d | 0d |  |  | SIT | 1.71 | 6.13 | No BL | Steve Evans |  | GREEN |  |  |  |  |
| 1298 | 1.4.1.4.5.4.12.9 | Review with SITWG (Batch 1) |  | 5d | 2024-11-29 | 2024-12-05 | 1297 |  |  | 2024-12-05 | 2024-12-11 | 0d | 9.8d | 0d |  | SI Test | SIT | 2.33 | 6.13 | Green | Steve Evans |  | GREEN |  |  |  |  |
| 1299 | 1.4.1.4.5.4.12.10 | SITWG endorse Theme 3 (Batch 1) | milestone | 0d | 2024-12-05 | 2024-12-05 | 1298 |  |  |  |  |  | 9.8d | 0d |  |  | SIT | 8.71 | 6.13 | No BL | Steve Evans |  | GREEN |  |  |  |  |
| 1300 | 1.4.1.4.5.4.12.11 | SITAG paper day | milestone | 0d | 2024-12-11 | 2024-12-11 | 1299FS+4d |  |  |  |  |  | 9.8d | 0d |  |  | SIT | 14.71 | 6.13 | No BL | Steve Evans |  | GREEN |  |  |  |  |
| 1301 | 1.4.1.4.5.4.12.12 | SITAG approve Theme 3 (Batch 1) | milestone | 0d | 2024-12-17 | 2024-12-17 | 1300FS+4d |  |  | 2024-12-18 | 2024-12-18 | 0d | 9.8d | 1d |  | SI Test | SIT | 20.71 | 6.13 | Green | Steve Evans |  | GREEN | T3-TE-0139 |  |  |  |
| 1302 | 1.4.1.4.5.4.12.13 | SIT Operational Scenarios & Test Cases Approved - Theme 3 (Batch 1 + 2) | milestone | 0d | 2024-12-18 | 2024-12-18 | 1305, 1288, 1301 |  |  | 2024-12-18 | 2024-12-18 | 0d | 8.8d | 0d |  | SI Test | SIT | 21.71 | 6.13 | Green | Steve Evans | SI Test, PP | GREEN | T3-TE-0119 | 31/7/24: baseline date change approved at esitag on 26/7/24 | Systems Integration Testing (SIT) | SITAG |
| 1303 | 1.4.1.4.5.4.13 | **Helix SDD and LLSD Development and Approval** |  | 1d | 2024-09-27 A | 2024-09-30 A |  | 100% |  | 2024-09-27 | 2024-09-30 | 0d |  |  |  | SI Test | SIT | -688.67 | 6.0 | Overdue Start | Steve Evans |  |  |  |  |  |  |
| 1304 | 1.4.1.4.5.4.13.1 | Development | milestone | 0d | 2024-09-27 A | 2024-09-27 A |  | 100% |  | 2024-09-27 | 2024-09-27 | 0d |  |  | start no earlier than 2024-09-27 | SI Test | SIT |  | 6.0 | Complete | Steve Evans |  | COMPLETE |  |  |  |  |
| 1305 | 1.4.1.4.5.4.13.2 | Approval | milestone | 0d | 2024-09-30 A | 2024-09-30 A |  | 100% |  | 2024-09-30 | 2024-09-30 | 0d |  |  | start no earlier than 2024-09-30 | SI Test | SIT |  | 6.0 | Complete | Steve Evans |  | COMPLETE |  |  |  |  |
| 1306 | 1.4.1.4.5.5 | **SIT Operational Programme RTTM** |  | 27d? | 2024-12-19 A | 2025-01-24 |  | 33% | 18.2d? | 2024-12-12 | 2025-01-17 | 0d | 759d |  |  | SI Test | SIT | -686.67 | 6.12 | Overdue Start | Steve Evans |  |  |  |  |  |  |
| 1307 | 1.4.1.4.5.5.1 | Develop Manual SIT Operational RTTM |  | 22d? | 2024-12-19 A | 2025-01-17 | 1302 | 40% | 13.2d? | 2024-12-12 | 2025-01-10 | 0d | 0d |  |  | SI Test | SIT |  | 6.12 | yellow | Steve Evans |  | RED |  |  |  |  |
| 1308 | 1.4.1.4.5.5.2 | Manual SIT Operational RTTM Complete | milestone | 0d | 2025-01-17 | 2025-01-17 | 1307 |  |  | 2025-01-10 | 2025-01-10 | 0d | 764d |  |  | SI Test | SIT | 51.71 | 6.12 | yellow | Steve Evans |  | RED |  |  |  |  |
| 1309 | 1.4.1.4.5.5.3 | Develop Automated SIT Operational RTTM |  | 5d | 2025-01-20 | 2025-01-24 | 1307 |  |  | 2025-01-13 | 2025-01-17 | 0d | 0d |  |  | SI Test | SIT | 54.33 | 6.12 | yellow | Steve Evans |  | RED |  |  |  |  |
| 1310 | 1.4.1.4.5.5.4 | Automated SIT Operational RTTM Complete | milestone | 0d | 2025-01-24 | 2025-01-24 | 1309 |  |  | 2025-01-17 | 2025-01-17 | 0d | 759d |  |  | SI Test | SIT | 58.71 | 6.12 | yellow | Steve Evans |  | RED |  |  |  |  |
| 1311 | 1.4.1.4.5.6 | **Gap analysis** |  | 54d? | 2025-02-17 | 2025-05-01 |  |  |  | 2025-02-17 | 2025-05-01 | 0d | 0d |  |  | SI Test | SIT | -693.67 | 6.13 | Overdue Start | Steve Evans |  |  |  |  |  | SITAG |
| 1312 | 1.4.1.4.5.6.1 | Identify gaps in test case coverage following RTTM review |  | 20d? | 2025-02-17 | 2025-03-14 | 1309SS+20d |  |  | 2025-02-17 | 2025-03-14 | 0d | 0d |  |  | SI Test | SIT | 82.33 | 6.13 | Green | Steve Evans |  | GREEN |  |  |  | SITAG |
| 1313 | 1.4.1.4.5.6.2 | Address gaps in test case coverage following RTTM review |  | 25d | 2025-03-03 | 2025-04-04 | 1312SS+10d |  |  | 2025-03-03 | 2025-04-04 | 0d | 0d |  |  | SI Test | SIT | 96.33 | 6.13 | Green | Steve Evans |  | GREEN |  |  |  | SITAG |
| 1314 | 1.4.1.4.5.6.3 | Gap analysis complete | milestone | 0d | 2025-04-04 | 2025-04-04 | 1313 |  |  | 2025-04-04 | 2025-04-04 | 0d | 0d |  |  | SI Test | SIT | 128.71 | 6.13 | Green | Steve Evans |  | GREEN |  |  |  | SITAG |
| 1315 | 1.4.1.4.5.6.4 | Test Script updates identified |  | 1d? | 2025-04-07 | 2025-04-07 | 1314 |  |  | 2025-04-07 | 2025-04-07 | 0d | 0d |  |  | SI Test | SIT | 131.33 | 6.13 | Green | Steve Evans |  | GREEN |  |  |  | SITAG |
| 1316 | 1.4.1.4.5.6.5 | Test Scripts updates |  | 1d | 2025-04-08 | 2025-04-08 | 1315 |  |  | 2025-04-08 | 2025-04-08 | 0d | 707d |  |  | SI Test | SIT | 132.33 | 6.13 | Green | Steve Evans |  | GREEN |  |  |  | SITAG |
| 1317 | 1.4.1.4.5.6.6 | RTTM Updated Additional Static RTTM WBS items |  | 10d | 2025-04-07 | 2025-04-18 | 1315FS-1d |  |  | 2025-04-07 | 2025-04-18 | 0d | 0d |  |  | SI Test | SIT | 131.33 | 6.13 | Green | Steve Evans |  | GREEN |  |  |  | SITAG |
| 1318 | 1.4.1.4.5.6.7 | Removal of de-scoped TCs from the RTTMs |  | 5d | 2025-04-14 | 2025-04-18 | 1317FS-5d |  |  | 2025-04-14 | 2025-04-18 | 0d | 699d |  |  | SI Test | SIT | 138.33 | 6.13 | Green | Steve Evans |  | GREEN |  |  |  | SITAG |
| 1319 | 1.4.1.4.5.6.8 | Update and stabilisation of all TC ADO IDs |  | 14d | 2025-04-14 | 2025-05-01 | 1317FS-5d |  |  | 2025-04-14 | 2025-05-01 | 0d | 690d |  |  | SI Test | SIT | 138.33 | 6.13 | Green | Steve Evans |  | GREEN |  |  |  | SITAG |
| 1320 | 1.4.1.4.5.6.9 | Addition and integration of Role tags to reqs in the Role RTTMs |  | 5d | 2025-04-14 | 2025-04-18 | 1317FS-5d |  |  | 2025-04-14 | 2025-04-18 | 0d | 699d |  |  | SI Test | SIT | 138.33 | 6.13 | Green | Steve Evans |  | GREEN |  |  |  | SITAG |
| 1321 | 1.4.1.4.5.6.10 | Update of the RTTM All sheet (porting of the individual RTTMs) |  | 7d | 2025-04-17 | 2025-04-25 | 1317FS-2d |  |  | 2025-04-17 | 2025-04-25 | 0d | 0d |  |  | SI Test | SIT | 141.33 | 6.13 | Green | Steve Evans |  | GREEN |  |  |  | SITAG |
| 1322 | 1.4.1.4.5.6.11 | Define Additional ADO Tags |  | 1d | 2025-04-16 | 2025-04-16 | 1317FS-3d |  |  | 2025-04-16 | 2025-04-16 | 0d | 701d |  |  | SI Test | SIT | 140.33 | 6.13 | Green | Steve Evans |  | GREEN |  |  |  | SITAG |
| 1323 | 1.4.1.4.5.6.12 | Functional RTTM ready for import into ADO | milestone | 0d | 2025-04-25 | 2025-04-25 | 1321 |  |  | 2025-04-25 | 2025-04-25 | 0d | 694d |  |  | SI Test | SIT | 149.71 | 6.13 | Green | Steve Evans |  | GREEN |  |  |  | SITAG |
| 1324 | 1.4.1.4.5.6.13 | Further Interative Deepdive on the requirements to testcase mapping |  | 9d | 2025-04-14 | 2025-04-24 | 1321FS-10d |  |  | 2025-04-14 | 2025-04-24 | 0d | 0d |  |  | SI Test | SIT | 138.33 | 6.13 | Green | Steve Evans |  | GREEN |  |  |  | SITAG |
| 1325 | 1.4.1.4.5.6.14 | Internal review |  | 5d | 2025-04-14 | 2025-04-18 | 1324FS-9d |  |  | 2025-04-14 | 2025-04-18 | 0d | 0d |  |  | SI Test | SIT | 138.33 | 6.13 | Green | Steve Evans |  | GREEN |  |  |  | SITAG |
| 1326 | 1.4.1.4.5.6.15 | Issue Static RTTM to Code Bodies |  | 1d? | 2025-04-22 | 2025-04-22 | 1325FS+1d |  |  | 2025-04-22 | 2025-04-22 | 0d | 0d |  |  | SI Test | SIT | 146.33 | 6.13 | Green | Steve Evans |  | GREEN |  |  |  | SITAG |
| 1327 | 1.4.1.4.5.6.16 | Code Body Acceptance of RTTM |  | 5d | 2025-04-23 | 2025-04-29 | 1326 |  |  | 2025-04-23 | 2025-04-29 | 0d | 0d |  |  | Code Bodies | SIT | 147.33 | 6.13 | Green | Steve Evans |  | RED |  |  |  |  |

Notes:
- 1290: 12/09/24 - Duration increased from 46 days to 78 days to reflect the SI Plan.
- 1301: 27/11/24 - New milestone added by Programme, awaiting formal SITAG approval.
- 1302: 13/11/24 - Theme 3 Batch 1 industry feedback received and script updates in progress, but review of feedback and update is running behind schedule. Forecast completion date is now a week after baseline, status set to Red.
- 1307: 13/11/24 - Programme is reviewing the timeframe for this recognising it crosses Christmas.
- 1312: 27/11/24 - Programme is updating these timeframes.
- 1313: 27/11/24 - Programme is updating these timeframes.
- 1314: 27/11/24 - Programme is updating these timeframes.
- 1315: 27/11/24 - Programme is updating these timeframes.
- 1316: 27/11/24 - Programme is updating these timeframes.
- 1317: 27/11/24 - Programme is updating these timeframes.
- 1318: 27/11/24 - Programme is updating these timeframes.
- 1319: 27/11/24 - Programme is updating these timeframes.
- 1320: 27/11/24 - Programme is updating these timeframes.
- 1321: 27/11/24 - Programme is updating these timeframes.
- 1322: 27/11/24 - Programme is updating these timeframes.
- 1323: 27/11/24 - Programme is updating these timeframes.
- 1324: 27/11/24 - Programme is updating these timeframes.
- 1325: 27/11/24 - Programme is updating these timeframes.
- 1326: 27/11/24 - Programme is updating these timeframes.
- 1327: 27/11/24 - Programme is updating these timeframes.

| ID | WBS | Task | Type | Duration | Start | Finish | Predecessors | Complete | Remaining | Baseline start | Baseline finish | Baseline duration | Baseline 1 start | Baseline 1 finish | Total slack | Free slack | Constraint | Baseline cost | Responsible | Text9 | Task Status | Update Version | Sched Status | MHHS Resource Name | RAG | Involved | MHHS Programme Phase | Milestone ID | Text29 | Tier |
| --- | --- | --- | --- | --- | --- | --- | --- | --- | --- | --- | --- | --- | --- | --- | --- | --- | --- | --- | --- | --- | --- | --- | --- | --- | --- | --- | --- | --- | --- | --- |
| 1328 | 1.4.1.4.5.7 | **DITL** |  | 8d? | 2024-10-08 | 2024-10-17 |  |  |  | 2024-10-08 | 2024-10-17 | 0d |  |  | 830d |  |  |  | SI Test | SIT | 6.33 | 6.13 | No BL | Dom Mooney |  |  |  |  |  |  |
| 1329 | 1.4.1.4.5.7.1 | Programme Cycle 2 Retro |  | 1d? | 2024-10-08 | 2024-10-08 |  |  |  | 2024-10-08 | 2024-10-08 | 0d |  |  | 830d | 0d | start no earlier than 2024-10-08 |  | SI Test | SIT | -49.67 | 6.13 | Overdue Start | Dom Mooney | RED |  |  |  |  |  |
| 1330 | 1.4.1.4.5.7.2 | Post-retro DITL Changes |  | 3d | 2024-10-09 | 2024-10-11 | 1329 |  |  | 2024-10-09 | 2024-10-11 | 0d |  |  | 830d | 0d |  |  | SI Test | SIT | -48.67 | 6.13 | Overdue Start | Dom Mooney | RED |  |  |  |  |  |
| 1331 | 1.4.1.4.5.7.3 | SRO Review |  | 2d | 2024-10-14 | 2024-10-15 | 1330 |  |  | 2024-10-14 | 2024-10-15 | 0d |  |  | 830d | 0d |  |  | SI Test | SIT | -43.67 | 6.13 | Overdue Start | Dom Mooney | RED |  |  |  |  |  |
| 1332 | 1.4.1.4.5.7.4 | Post-SRO Review Changes |  | 1d? | 2024-10-16 | 2024-10-16 | 1331 |  |  | 2024-10-16 | 2024-10-16 | 0d |  |  | 830d | 0d |  |  | SI Test | SIT | -41.67 | 6.13 | Overdue Start | Dom Mooney | RED |  |  |  |  |  |
| 1333 | 1.4.1.4.5.7.5 | Publish Cycle 3 DITL / Cycle 3 DITL Online Sessions for SIT PPs |  | 1d? | 2024-10-17 | 2024-10-17 | 1332 |  |  | 2024-10-17 | 2024-10-17 | 0d |  |  | 830d |  |  |  | SI Test, PPs | SIT | -40.67 | 6.13 | Overdue Start | Dom Mooney | RED |  |  |  |  |  |
| 1334 | 1.4.1.4.5.8 | **Environments (SIT B)** |  | 0d | 2024-10-07 A | 2024-10-07 A |  | 100% |  | 2024-10-07 | 2024-10-07 | 0d | 2024-09-03 | 2024-09-09 |  |  |  | -0 | N/A | SIT |  | 5.0 |  | Heath Thomas |  | N/A | Systems Integration Testing (SIT) |  |  |  |
| 1335 | 1.4.1.4.5.8.1 | **PP Environments (SIT B)** |  | 0d | 2024-10-07 A | 2024-10-07 A |  | 100% |  | 2024-10-07 | 2024-10-07 | 0d | 2024-09-03 | 2024-09-09 |  |  |  | -0 | N/A | SIT |  | 5.0 |  | Heath Thomas |  | N/A | Systems Integration Testing (SIT) |  |  |  |
| 1336 | 1.4.1.4.5.8.1.1 | Deployment of MHHS solution code to SIT B environments | milestone | 0d | 2024-10-07 A | 2024-10-07 A | 141 | 100% |  | 2024-10-07 | 2024-10-07 | 0d | 2024-09-03 | 2024-09-09 |  |  | start no earlier than 2024-08-27 |  | PP | SIT |  | 5.21 | Complete | Heath Thomas | COMPLETE | SI Test | Systems Integration Testing (SIT) |  |  |  |
| 1337 | 1.4.1.4.5.8.2 | **SI Environments (SIT B)** |  | 0d | 2024-10-07 A | 2024-10-07 A |  | 100% |  | 2024-10-07 | 2024-10-07 | 0d | 2024-09-03 | 2024-09-09 |  |  |  | -0 | N/A | SIT |  | 5.0 |  | Heath Thomas |  | N/A | Systems Integration Testing (SIT) |  |  |  |
| 1338 | 1.4.1.4.5.8.2.1 | Coordinate deployment of MHHS solution code to SIT Participants' SIT B environments | milestone | 0d | 2024-10-07 A | 2024-10-07 A | 1336SS | 100% |  | 2024-10-07 | 2024-10-07 | 0d | 2024-09-03 | 2024-09-09 |  |  |  |  | SI Test | SIT |  | 5.21 | Complete | Heath Thomas | COMPLETE | PP | Systems Integration Testing (SIT) |  |  |  |
| 1339 | 1.4.1.4.6 | **SIT Operational Test Readiness Report** |  | 33d? | 2024-08-05 | 2024-09-18 |  |  |  | 2024-08-05 | 2024-09-18 | 151d | 2025-01-07 | 2025-03-03 |  |  |  | -0 | N/A | SIT |  | 6.0 |  | Steve Evans |  | N/A | Systems Integration Testing (SIT) |  |  |  |
| 1340 | 1.4.1.4.6.1 | **PP SIT Operational Test Readiness Report** |  | 0d | 2024-08-05 | 2024-08-05 |  |  |  | 2024-08-05 | 2024-08-05 | 131d | 2025-01-07 | 2025-02-17 |  |  |  | -0 | N/A | SIT |  | 6.11 |  | Steve Evans |  | N/A | Systems Integration Testing (SIT) |  |  |  |
| 1341 | 1.4.1.4.6.1.1 | Test Readiness Report submitted to Programme for assurance | milestone | 0d | 2024-12-20 | 2024-12-20 | 407FF |  |  | 2024-12-20 | 2024-12-20 | 20d | 2025-01-07 | 2025-02-03 | 769d | 0d |  |  | PP | SIT | 23.71 | 6.11 | Green | Steve Evans | GREEN | SI Test | Systems Integration Testing (SIT) |  |  |  |
| 1342 | 1.4.1.4.6.2 | **SI SIT Operational Test Readiness Report** |  | 35d | 2024-12-02 | 2025-01-17 |  |  |  | 2024-08-05 | 2025-01-17 | 40d | 2025-01-07 | 2025-03-03 | 68d |  |  |  | N/A | SIT |  | 6.11 |  | Steve Evans |  | N/A | Systems Integration Testing (SIT) |  |  |  |
| 1343 | 1.4.1.4.6.2.1 | Assure Test Participants' Test Readiness Reports |  | 5d | 2025-01-06 | 2025-01-10 | 1341FS+10d |  |  | 2024-08-05 | 2025-01-10 | 35d | 2025-01-07 | 2025-02-24 | 769d |  |  |  | SI Test | SIT | 40.33 | 6.11 | Green | Steve Evans | GREEN | PP,IPA | Systems Integration Testing (SIT) |  |  |  |
| 1344 | 1.4.1.4.6.2.2 | Develop Overarching SIT Operational Test Readiness Report |  | 30d | 2024-12-02 | 2025-01-10 |  |  |  | 2024-12-02 | 2025-01-10 | 20d | 2025-01-28 | 2025-02-24 | 68d | 0d | start no earlier than 2024-12-02 |  | SI Test | SIT | 5.33 | 6.0 | Green | Steve Evans | GREEN |  | Systems Integration Testing (SIT) |  |  |  |
| 1345 | 1.4.1.4.6.2.3 | Artefact review (via SITAG) and updates |  | 5d | 2025-01-13 | 2025-01-17 | 1344 |  |  | 2025-01-13 | 2025-01-17 | 5d | 2025-02-25 | 2025-03-03 | 68d | 0d |  |  | SI Test | SIT | 47.33 | 5.0 | Green | Steve Evans | GREEN | PP,IPA | Systems Integration Testing (SIT) |  |  |  |
| 1346 | 1.4.1.4.6.3 | **Progress reporting** |  | 1d? | 2024-08-05 | 2024-08-05 |  |  |  |  |  |  |  |  | 883d |  |  |  | SI Test | SIT | -94.67 | 6.12 | Overdue Start | Steve Evans | RED |  |  |  |  |  |
| 1347 | 1.4.1.4.6.3.1 | Determine methodology |  | 1d? | 2024-08-05 | 2024-08-05 |  |  |  |  |  |  |  |  | 883d |  |  |  | SI Test | SIT | -113.67 | 6.12 | Overdue Start | Steve Evans | RED |  |  |  |  |  |
| 1348 | 1.4.1.4.6.3.2 | Implement reporting |  | 1d? | 2024-08-05 | 2024-08-05 |  |  |  |  |  |  |  |  | 883d |  |  |  | SI Test | SIT | -113.67 | 6.12 | Overdue Start | Steve Evans | RED |  |  |  |  |  |
| 1349 | 1.4.1.4.6.4 | SIT Operational Testing Preparation Complete | milestone | 0d | 2025-01-17 | 2025-01-17 | 407, 1175, 1181, 1302, 1345 |  |  | 2025-01-17 | 2025-01-17 | 0d | 2025-03-10 | 2025-03-10 | 68d | 7d | finish no earlier than 2024-10-04 |  | SI Test | SIT | 51.71 | 6.0 | Green | Roger Robar | GREEN | PP,IPA | Systems Integration Testing (SIT) | T2-TE-0750 | SITAG | T2 |
| 1350 | 1.4.1.4.7 | **Regression Test Preparation** |  | 130d? | 2024-11-18 A | 2025-05-16 |  | 3% | 126.69d? | 2024-09-16 | 2025-05-16 | 0d |  |  | 679d |  |  |  | SI Test | SIT | -686.67 | 6.13 | Overdue Start | Roger Robar |  |  |  |  | SITAG |  |
| 1351 | 1.4.1.4.7.1 | **Regression Test Approach** |  | 44d | 2024-11-18 A | 2025-01-16 |  | 12% | 38.72d | 2024-09-16 | 2024-11-20 | 0d |  |  | 765d |  |  |  | SI Test | SIT | -686.67 | 6.13 | Overdue Start | Roger Robar |  |  |  |  | SITAG |  |
| 1352 | 1.4.1.4.7.1.1 | Develop approach doc |  | 15d | 2024-11-18 A | 2024-12-06 |  | 20% | 12d | 2024-11-18 | 2024-12-13 | 0d |  |  | 32d | 0d | start no earlier than 2024-09-16 |  | SI Test | SIT |  | 6.13 | Green | Roger Robar | GREEN |  |  |  |  |  |
| 1353 | 1.4.1.4.7.1.2 | SRO review of approach doc |  | 3d | 2024-12-09 | 2024-12-11 | 1352 |  |  | 2024-12-16 | 2024-12-18 | 0d |  |  | 32d | 0d |  |  | SI Test | SIT | 12.33 | 6.13 | Green | Roger Robar | GREEN |  |  |  |  |  |
| 1354 | 1.4.1.4.7.1.3 | Incorporate SRO feedback into approach doc |  | 1d | 2024-12-12 | 2024-12-12 | 1353 |  |  | 2024-12-19 | 2024-12-20 | 0d |  |  | 32d | 0d |  |  | SI Test | SIT | 15.33 | 6.13 | Green | Roger Robar | GREEN |  |  |  |  |  |
| 1355 | 1.4.1.4.7.1.4 | Industry review of approach |  | 5d | 2024-12-13 | 2024-12-19 | 1354 |  |  |  |  |  |  |  | 32d | 0d |  |  |  |  | 16.33 | 6.13 | No BL |  | GREEN |  |  |  |  |  |
| 1356 | 1.4.1.4.7.1.5 | SITWG paper day | milestone | 0d | 2024-12-20 | 2024-12-20 | 1355FS+1d |  |  | 2024-12-20 | 2024-12-20 |  |  |  | 32d | 0d |  |  | SI Test | SIT | 23.71 | 6.13 | Green | Roger Robar | GREEN |  |  |  |  |  |
| 1357 | 1.4.1.4.7.1.6 | SITWG Recommendation | milestone | 0d | 2025-01-08 | 2025-01-08 | 1356FS+13d |  |  | 2025-01-08 | 2025-01-08 |  |  |  | 765d | 0d |  |  | SI Test | SIT | 42.71 | 6.13 | Green | Roger Robar | GREEN |  |  |  |  |  |
| 1358 | 1.4.1.4.7.1.7 | Incorporate SITWG feedback into approach doc |  | 1d | 2025-01-09 | 2025-01-09 | 1357 |  |  | 2025-01-09 | 2025-01-09 | 0d |  |  | 765d | 0d |  |  | SI Test | SIT | 43.33 | 6.13 | Green | Roger Robar | GREEN |  |  |  |  |  |
| 1359 | 1.4.1.4.7.1.8 | SITAG paper day | milestone | 0d | 2025-01-09 | 2025-01-09 | 1358 |  |  | 2025-01-09 | 2025-01-09 | 0d |  |  | 765d | 0d |  |  | SI Test | SIT | 43.71 | 6.13 | Green | Roger Robar | GREEN |  |  |  |  |  |
| 1360 | 1.4.1.4.7.1.9 | SITAG (inc SRO) Approval | milestone | 0d | 2025-01-16 | 2025-01-16 | 1359FS+5d |  |  | 2025-01-16 | 2025-01-16 | 0d |  |  | 765d | 0d |  |  | SI Test | SIT | 50.71 | 6.13 | Green | Roger Robar | GREEN |  |  |  |  |  |
| 1361 | 1.4.1.4.7.1.10 | SIT Regression Testing Approach and Plan Approval | milestone | 0d | 2025-01-16 | 2025-01-16 | 1360 |  |  | 2025-01-16 | 2025-01-16 | 0d |  |  | 765d |  |  |  | SI Test | SIT | 50.71 | 6.13 | Green | Roger Robar | GREEN |  |  | T3-TE-0123 | SITAG |  |

Notes:
- 1329: 27/11/24 - Programme is updating these timeframes.
- 1330: 27/11/24 - Programme is updating these timeframes.
- 1331: 27/11/24 - Programme is updating these timeframes.
- 1332: 27/11/24 - Programme is updating these timeframes.
- 1333: 27/11/24 - Programme is updating these timeframes.
- 1340: 12/09/24 - Forecast start date brought forward to 05/08/24 in line with the SI Plan.
- 1341: 12/09/24 - Forecast start date brought forward to 05/08/24 in line with the SI Plan.
- 1343: 12/09/24 - Duration increased from 5 days to 25 days in line with the SI Plan.
- 1344: 12/09/24 - Duration increased from 4 days to 18 days in line with the SI Plan.
- 1346: 08/11/24 - Dates for this activity are being determined.
- 1347: 08/11/24 - Dates for this activity are being determined.
- 1348: 08/11/24 - Dates for this activity are being determined.

| ID | WBS | Task | Type | Duration | Start | Finish | Predecessors | Complete | Remaining | Baseline start | Baseline finish | Baseline duration | Total slack | Free slack | Constraint | Responsible | Text9 | Task Status | Update Version | Sched Status | MHHS Resource Name | RAG | Milestone ID | Programme Governance Forum responsible for decisio | Text29 |
| --- | --- | --- | --- | --- | --- | --- | --- | --- | --- | --- | --- | --- | --- | --- | --- | --- | --- | --- | --- | --- | --- | --- | --- | --- | --- |
| 1362 | 1.4.1.4.7.2 | **Regression Test Suite** |  | 62d | 2024-12-23 | 2025-03-18 |  |  |  | 2025-01-17 | 2025-03-18 | 0d | 32d |  |  | SI Test | SIT | -686.67 | 6.13 | Overdue Start | Roger Robar |  |  |  |  |
| 1363 | 1.4.1.4.7.2.1 | Build Regression Test Suite |  | 24d | 2024-12-23 | 2025-01-23 | 1356 |  |  | 2025-01-17 | 2025-02-06 | 0d | 32d | 0d |  | SI Test | SIT | 26.33 | 6.13 | Green | Roger Robar | GREEN |  |  |  |
| 1364 | 1.4.1.4.7.2.2 | LDP review of Regression Test Suite |  | 3d | 2025-01-24 | 2025-01-28 | 1363 |  |  |  |  |  | 32d | 0d |  |  |  | 58.33 | 6.13 | No BL |  | GREEN |  |  |  |
| 1365 | 1.4.1.4.7.2.3 | SRO Review of regression suite doc |  | 3d | 2025-01-29 | 2025-01-31 | 1364 |  |  | 2025-02-07 | 2025-02-20 | 0d | 32d | 0d |  | SI Test | SIT | 63.33 | 6.13 | Green | Roger Robar | GREEN |  |  |  |
| 1366 | 1.4.1.4.7.2.4 | Incorporate SRO feedback into regression suite doc |  | 4d | 2025-02-03 | 2025-02-06 | 1365 |  |  | 2025-02-21 | 2025-02-27 |  | 32d | 0d |  | SI Test | SIT | 68.33 | 6.13 | Green | Roger Robar | GREEN |  |  |  |
| 1367 | 1.4.1.4.7.2.5 | Industry review of Regression Test Suite |  | 10d | 2025-02-07 | 2025-02-20 | 1366 |  |  |  |  |  | 73d | 0d |  |  |  | 72.33 | 6.13 | No BL |  | GREEN |  |  |  |
| 1368 | 1.4.1.4.7.2.6 | Incorporate Industry feedback into regression suite doc |  | 5d | 2025-02-21 | 2025-02-27 | 1367 |  |  |  |  |  | 73d | 0d |  |  |  | 86.33 | 6.13 | No BL |  | GREEN |  |  |  |
| 1369 | 1.4.1.4.7.2.7 | SITWG paper day | milestone | 0d | 2025-02-27 | 2025-02-27 | 1368 |  |  | 2025-02-27 | 2025-02-27 |  | 73d | 0d |  | SI Test | SIT | 92.71 | 6.13 | Green | Roger Robar | GREEN |  |  |  |
| 1370 | 1.4.1.4.7.2.8 | SITWG recommends regression suite doc | milestone | 0d | 2025-03-06 | 2025-03-06 | 1369FS+5d |  |  | 2025-03-06 | 2025-03-06 | 0d | 73d | 0d |  | SI Test | SIT | 99.71 | 6.13 | Green | Roger Robar | GREEN |  |  |  |
| 1371 | 1.4.1.4.7.2.9 | Incorporate SITWG feedback into regression suite doc | milestone | 0d | 2025-03-06 | 2025-03-06 | 1370 |  |  | 2025-03-07 | 2025-03-11 | 0d | 73d | 0d |  | SI Test | SIT | 99.71 | 6.13 | Green | Roger Robar | GREEN |  |  |  |
| 1372 | 1.4.1.4.7.2.10 | SITAG paper day | milestone | 0d | 2025-03-11 | 2025-03-11 | 1371FS+3d |  |  | 2025-03-11 | 2025-03-11 | 0d | 73d | 0d |  | SI Test | SIT | 104.71 | 6.13 | Green | Roger Robar | GREEN |  |  |  |
| 1373 | 1.4.1.4.7.2.11 | SITAG (inc SRO) Approval of regression suite doc | milestone | 0d | 2025-03-18 | 2025-03-18 | 1372FS+5d |  |  | 2025-03-18 | 2025-03-18 |  | 722d | 0d |  | SI Test | SIT | 111.71 | 6.13 | Green | Roger Robar | GREEN |  |  |  |
| 1374 | 1.4.1.4.7.2.12 | SIT Regression Approval | milestone | 0d | 2025-03-18 | 2025-03-18 | 1373 |  |  | 2025-03-18 | 2025-03-18 | 0d | 722d |  |  | SI Test | SIT | 111.71 | 6.13 | Green | Roger Robar | GREEN | T3-TE-0122 | SITAG | SITAG |
| 1375 | 1.4.1.4.7.3 | **Regression Test Data Load Window (SIT Functional and Migration) - SIT A** |  | 1d? | 2025-04-28 | 2025-04-29 |  |  |  | 2025-03-14 | 2025-03-17 | 0d |  |  |  | SI Test | SIT | -686.67 | 6.1 | Overdue Start | Richard Puddephatt |  |  |  |  |
| 1376 | 1.4.1.4.7.3.1 | Data Load preparation activities |  | 30d? | 2025-02-21 | 2025-04-03 | 1366 |  |  |  |  |  | 22d | 17d | start no earlier than 2025-02-21 | SI Test |  | 86.33 | 6.13 | No BL |  | GREEN |  |  |  |
| 1377 | 1.4.1.4.7.3.2 | Regression Test Data Load Start | milestone | 0d? | 2025-04-28 | 2025-04-28 | 1527, 1474FS+1d, 1531FS+1d, 1376 |  |  | 2025-04-28 | 2025-04-28 | 0d | 5d | 0d |  | SI Test | SIT | 152.71 | 6.1 | Green | Richard Puddephatt | GREEN | T2-TE-1000 |  |  |
| 1378 | 1.4.1.4.7.3.3 | Regression Test Data Load Window |  | 14d | 2025-04-29 | 2025-05-16 | 1377 |  |  | 2025-04-28 | 2025-05-16 | 0d | 5d | 0d | start no earlier than 2025-04-28 | SI Test | SIT | 153.33 | 6.1 | Green | Richard Puddephatt | GREEN |  |  |  |
| 1379 | 1.4.1.4.8 | **Single Instance ADO** |  | 32d? | 2024-08-21 A | 2024-10-03 |  | 98% | 0.65d? | 2024-08-21 | 2024-10-03 | 0d | 840d |  |  | SI Test | SIT | -701.67 | 6.1 | Overdue Start | Heath Thomas | RED |  |  |  |
| 1380 | 1.4.1.4.8.1 | **Single ADO Project for all Cohorts - Implementation and Test Phase** |  | 30d? | 2024-08-21 A | 2024-10-01 A |  | 100% |  | 2024-08-21 | 2024-10-01 | 0d |  |  |  | SI Test | SIT | -701.67 | 6.1 | Overdue Start | Heath Thomas | RED |  |  |  |
| 1381 | 1.4.1.4.8.1.1 | Create test plans and suites in master project |  | 2d? | 2024-08-21 A | 2024-08-22 A |  | 100% |  | 2024-08-21 | 2024-08-22 | 0d |  |  | finish no earlier than 2024-08-22 | SI Test | SIT |  | 6.1 | Complete | Heath Thomas | COMPLETE |  |  |  |
| 1382 | 1.4.1.4.8.1.2 | Create area paths / iterations |  | 2d? | 2024-08-21 A | 2024-08-22 A |  | 100% |  | 2024-08-21 | 2024-08-22 | 0d |  |  | finish no earlier than 2024-08-22 | SI Test | SIT |  | 6.1 | Complete | Heath Thomas | COMPLETE |  |  |  |
| 1383 | 1.4.1.4.8.1.3 | Create IAM roles |  | 2d? | 2024-08-21 A | 2024-08-22 A |  | 100% |  | 2024-08-21 | 2024-08-22 | 0d |  |  | finish no earlier than 2024-08-22 | SI Test | SIT |  | 6.1 | Complete | Heath Thomas | COMPLETE |  |  |  |
| 1384 | 1.4.1.4.8.1.4 | Add users to roles |  | 1d? | 2024-08-23 A | 2024-08-23 A |  | 100% |  | 2024-08-23 | 2024-08-23 | 0d |  |  | start no earlier than 2024-08-23 | SI Test | SIT |  | 6.1 | Complete | Heath Thomas | COMPLETE |  |  |  |
| 1385 | 1.4.1.4.8.1.5 | **Testing permissions** |  | 2d? | 2024-08-27 A | 2024-08-28 A |  | 100% |  | 2024-08-27 | 2024-08-28 | 0d |  |  |  | SI Test | SIT |  | 6.1 | Complete | Heath Thomas | COMPLETE |  |  |  |
| 1386 | 1.4.1.4.8.1.5.1 | Adding tests |  | 2d? | 2024-08-27 A | 2024-08-28 A |  | 100% |  | 2024-08-27 | 2024-08-28 | 0d |  |  | finish no earlier than 2024-08-28 | SI Test | SIT |  | 6.1 | Complete | Heath Thomas | COMPLETE |  |  |  |
| 1387 | 1.4.1.4.8.1.5.2 | Deleting tests |  | 2d? | 2024-08-27 A | 2024-08-28 A |  | 100% |  | 2024-08-27 | 2024-08-28 | 0d |  |  | finish no earlier than 2024-08-28 | SI Test | SIT |  | 6.1 | Complete | Heath Thomas | COMPLETE |  |  |  |
| 1388 | 1.4.1.4.8.1.5.3 | Adding tests to incorrect Cohort |  | 2d? | 2024-08-27 A | 2024-08-28 A |  | 100% |  | 2024-08-27 | 2024-08-28 | 0d |  |  | finish no earlier than 2024-08-28 | SI Test | SIT |  | 6.1 | Complete | Heath Thomas | COMPLETE |  |  |  |
| 1389 | 1.4.1.4.8.1.5.4 | Add / delete defects |  | 2d? | 2024-08-27 A | 2024-08-28 A |  | 100% |  | 2024-08-27 | 2024-08-28 | 0d |  |  | finish no earlier than 2024-08-28 | SI Test | SIT |  | 6.1 | Complete | Heath Thomas | COMPLETE |  |  |  |
| 1390 | 1.4.1.4.8.1.6 | Migrate defects from cohort project to master - Option 2 |  | 3d | 2024-09-23 A | 2024-09-25 A |  | 100% |  | 2024-09-23 | 2024-09-25 | 0d |  |  | start no earlier than 2024-09-23 | SI Test | SIT |  | 6.1 | Complete | Heath Thomas | COMPLETE |  |  |  |
| 1391 | 1.4.1.4.8.1.7 | Testing Permissions - Evidence attachment security |  | 10d? | 2024-09-18 A | 2024-10-01 A |  | 100% |  | 2024-09-18 | 2024-10-01 | 0d |  |  | finish no earlier than 2024-10-01 | SI Test | SIT |  | 6.1 | Complete | Heath Thomas | COMPLETE |  |  |  |

Notes:
- 1377: 20/11/24 - Milestone ID assigned to this activity but no change to the date. Approved by SITAG on 20/11/24.

| ID | WBS | Task | Duration | Start | Finish | Complete | Remaining | Baseline start | Baseline finish | Baseline duration | Total slack | Constraint | Responsible | Text9 | Task Status | Update Version | Sched Status | MHHS Resource Name | RAG |
| --- | --- | --- | --- | --- | --- | --- | --- | --- | --- | --- | --- | --- | --- | --- | --- | --- | --- | --- | --- |
| 1392 | 1.4.1.4.8.2 | **ADO Dashboard Updates** | 20d? | 2024-09-03 A | 2024-09-30 A | 100% |  | 2024-09-03 | 2024-09-30 | 0d |  |  | SI Test | SIT | -701.67 | 6.1 | Overdue Start | Heath Thomas |  |
| 1393 | 1.4.1.4.8.2.1 | Update reporting dashboards in ADO | 3d | 2024-09-03 A | 2024-09-05 A | 100% |  | 2024-09-03 | 2024-09-05 | 0d |  | start no earlier than 2024-09-03 | SI Test | SIT |  | 6.1 | Complete | Heath Thomas | COMPLETE |
| 1394 | 1.4.1.4.8.2.2 | Review dashboards with SI LDP leads | 16d | 2024-09-06 A | 2024-09-27 A | 100% |  | 2024-09-06 | 2024-09-27 | 0d |  | start no earlier than 2024-09-06 | SI Test | SIT |  | 6.1 | Complete | Heath Thomas | COMPLETE |
| 1395 | 1.4.1.4.8.2.3 | Review dashboards with SRO | 16d | 2024-09-09 A | 2024-09-30 A | 100% |  | 2024-09-09 | 2024-09-30 | 0d |  | start no earlier than 2024-09-09 | SI Test | SIT |  | 6.1 | Complete | Heath Thomas | COMPLETE |
| 1396 | 1.4.1.4.8.2.4 | Update dashboards following review | 2d | 2024-09-12 A | 2024-09-13 A | 100% |  | 2024-09-12 | 2024-09-13 | 0d |  | start no earlier than 2024-09-12 | SI Test | SIT |  | 6.1 | Complete | Heath Thomas | COMPLETE |
| 1397 | 1.4.1.4.8.2.5 | Document changes to dashboard creation process | 4d | 2024-09-16 A | 2024-09-19 A | 100% |  | 2024-09-16 | 2024-09-19 | 0d |  | start no earlier than 2024-09-16 | SI Test | SIT |  | 6.1 | Complete | Heath Thomas | COMPLETE |
| 1398 | 1.4.1.4.8.2.6 | Update SIT Dashboards for Sprints 4.1 & 4.2 across all Cohorts | 1d? | 2024-09-03 A | 2024-09-03 A | 100% |  | 2024-09-03 | 2024-09-03 | 0d |  | start no earlier than 2024-09-03 | SI Test | SIT |  | 6.1 | Complete | Heath Thomas | COMPLETE |
| 1399 | 1.4.1.4.8.3 | **Reporting Changes - PowerBI & QIP** | 23d? | 2024-08-23 A | 2024-09-24 | 70% | 6.9d? | 2024-08-23 | 2024-09-24 | 0d | 847d |  | SI Test | SIT | -701.67 | 6.1 | Overdue Start | Heath Thomas |  |
| 1400 | 1.4.1.4.8.3.1 | Design, Create and ETL ADO Entities into PowerBI Data Model | 1d? | 2024-08-23 A | 2024-08-23 A | 100% |  | 2024-08-23 | 2024-08-23 | 0d |  | start no earlier than 2024-08-23 | SI Test | SIT |  | 6.1 | Complete | Heath Thomas | COMPLETE |
| 1401 | 1.4.1.4.8.3.2 | Determine Relationships between ADO Entities & Attributes | 1d? | 2024-08-27 A | 2024-08-27 A | 100% |  | 2024-08-27 | 2024-08-27 | 0d |  | start no earlier than 2024-08-27 | SI Test | SIT |  | 6.1 | Complete | Heath Thomas | COMPLETE |
| 1402 | 1.4.1.4.8.3.3 | Create Relevant Dax Measures | 1d? | 2024-08-28 A | 2024-08-28 A | 100% |  | 2024-08-28 | 2024-08-28 | 0d |  | start no earlier than 2024-08-28 | SI Test | SIT |  | 6.1 | Complete | Heath Thomas | COMPLETE |
| 1403 | 1.4.1.4.8.3.4 | Design & Build Visualisations (Graphs) | 1d? | 2024-08-29 A | 2024-08-29 A | 100% |  | 2024-08-29 | 2024-08-29 | 0d |  | start no earlier than 2024-08-29 | SI Test | SIT |  | 6.1 | Complete | Heath Thomas | COMPLETE |
| 1404 | 1.4.1.4.8.3.5 | Implement Filters | 1d? | 2024-09-23 A | 2024-09-23 A | 100% |  | 2024-09-23 | 2024-09-23 | 0d |  | start no earlier than 2024-09-23 | SI Test | SIT |  | 6.1 | Complete | Heath Thomas | COMPLETE |
| 1405 | 1.4.1.4.8.3.6 | Check Data Quality & Integrity | 1d? | 2024-09-24 A | 2024-09-24 A | 100% |  | 2024-09-24 | 2024-09-24 | 0d |  | start no earlier than 2024-09-24 | SI Test | SIT |  | 6.1 | Complete | Heath Thomas | COMPLETE |
| 1406 | 1.4.1.4.8.3.7 | Performance Optimisation | 1d? | 2024-09-24 A | 2024-09-24 A | 100% |  | 2024-09-24 | 2024-09-24 | 0d |  | start no earlier than 2024-09-24 | SI Test | SIT |  | 6.1 | Complete | Heath Thomas | COMPLETE |
| 1407 | 1.4.1.4.8.3.8 | Publish (QIP) | 1d? | 2024-09-04 | 2024-09-04 |  |  | 2024-09-04 | 2024-09-04 | 0d | 861d | start no earlier than 2024-09-04 | SI Test | SIT | -83.67 | 6.1 | Overdue Start | Heath Thomas | RED |
| 1408 | 1.4.1.4.8.3.9 | Review & UAT | 1d? | 2024-09-05 | 2024-09-05 |  |  | 2024-09-05 | 2024-09-05 | 0d | 860d | start no earlier than 2024-09-05 | SI Test | SIT | -82.67 | 6.1 | Overdue Start | Heath Thomas | RED |
| 1409 | 1.4.1.4.8.3.10 | QIP Training Material & User Guides | 1d? | 2024-09-10 | 2024-09-10 |  |  | 2024-09-10 | 2024-09-10 | 0d | 857d | start no earlier than 2024-09-10 | SI Test | SIT | -77.67 | 6.1 | Overdue Start | Heath Thomas | RED |
| 1410 | 1.4.1.4.8.4 | **Reporting Changes - Daily Excel Extract & PDF** | 2d | 2024-09-05 A | 2024-09-06 A | 100% |  | 2024-09-05 | 2024-09-06 | 0d |  |  | SI Test | SIT | -701.67 | 6.1 | Overdue Start | Heath Thomas | RED |
| 1411 | 1.4.1.4.8.4.1 | Excel Daily Report changes (Refer to above) | 2d | 2024-09-05 A | 2024-09-06 A | 100% |  | 2024-09-05 | 2024-09-06 | 0d |  | start no earlier than 2024-09-05 | SI Test | SIT |  | 6.1 | Complete | Heath Thomas | COMPLETE |
| 1412 | 1.4.1.4.8.4.2 | PDF Daily Report changes (Refer to Above) | 2d | 2024-09-05 A | 2024-09-06 A | 100% |  | 2024-09-05 | 2024-09-06 | 0d |  | start no earlier than 2024-09-05 | SI Test | SIT |  | 6.1 | Complete | Heath Thomas | COMPLETE |
| 1413 | 1.4.1.4.8.5 | **Documentation Updates** | 23d? | 2024-09-02 A | 2024-10-02 A | 100% |  | 2024-09-02 | 2024-10-02 | 0d |  |  | SI Test | SIT | -701.67 | 6.1 | Overdue Start | Heath Thomas |  |
| 1414 | 1.4.1.4.8.5.1 | Changes to onboarding process (security) | 10d | 2024-09-02 A | 2024-09-13 A | 100% |  | 2024-09-02 | 2024-09-13 | 0d |  | start no earlier than 2024-09-02 | SI Test | SIT |  | 6.1 | Complete | Heath Thomas | COMPLETE |
| 1415 | 1.4.1.4.8.5.2 | Update the documents on loading tests into ADO? | 10d | 2024-09-02 A | 2024-09-13 A | 100% |  | 2024-09-02 | 2024-09-13 | 0d |  | start no earlier than 2024-09-02 | SI Test | SIT |  | 6.1 | Complete | Heath Thomas | COMPLETE |
| 1416 | 1.4.1.4.8.5.3 | Update ADO Training material | 10d | 2024-09-02 A | 2024-09-13 A | 100% |  | 2024-09-02 | 2024-09-13 | 0d |  | start no earlier than 2024-09-02 | SI Test | SIT |  | 6.1 | Complete | Heath Thomas | COMPLETE |
| 1417 | 1.4.1.4.8.5.4 | Update ADO User Guide | 10d | 2024-09-02 A | 2024-09-13 A | 100% |  | 2024-09-02 | 2024-09-13 | 0d |  | start no earlier than 2024-09-02 | SI Test | SIT |  | 6.1 | Complete | Heath Thomas | COMPLETE |
| 1418 | 1.4.1.4.8.5.5 | Update ADO Configuration document | 10d | 2024-09-02 A | 2024-09-13 A | 100% |  | 2024-09-02 | 2024-09-13 | 0d |  | start no earlier than 2024-09-02 | SI Test | SIT |  | 6.1 | Complete | Heath Thomas | COMPLETE |
| 1419 | 1.4.1.4.8.5.6 | Update ADO Training Material and User Guide following SRO review | 1d? | 2024-10-02 A | 2024-10-02 A | 100% |  | 2024-10-02 | 2024-10-02 | 0d |  | start no earlier than 2024-10-02 | SI Test | SIT |  | 6.1 | Complete | Heath Thomas | COMPLETE |

Notes:
- 1407: 13/11/24 - This is on hold, assessed whether this is needed and if deemed so, will be resumed.
- 1408: 13/11/24 - This is on hold, assessed whether this is needed and if deemed so, will be resumed.
- 1409: 13/11/24 - This is on hold, assessed whether this is needed and if deemed so, will be resumed.

| ID | WBS | Task | Type | Duration | Start | Finish | Predecessors | Complete | Remaining | Baseline start | Baseline finish | Baseline duration | Baseline 1 start | Baseline 1 finish | Total slack | Constraint | Baseline cost | Responsible | Text9 | Task Status | Update Version | Sched Status | MHHS Resource Name | RAG | Involved | MHHS Programme Phase | Text29 | Artefact ID | Milestone ID | Tier | Future RAG |
| --- | --- | --- | --- | --- | --- | --- | --- | --- | --- | --- | --- | --- | --- | --- | --- | --- | --- | --- | --- | --- | --- | --- | --- | --- | --- | --- | --- | --- | --- | --- | --- |
| 1420 | 1.4.1.4.8.6 | **ADO Changes - Review Stage** |  | 19d? | 2024-09-09 A | 2024-10-03 A |  | 100% |  | 2024-09-09 | 2024-10-03 | 0d |  |  |  |  |  | SI Test | SIT | -701.67 | 6.1 | Overdue Start | Heath Thomas |  |  |  |  |  |  |  |  |
| 1421 | 1.4.1.4.8.6.1 | Review implementation with SI LDP leads |  | 1d? | 2024-09-27 A | 2024-09-27 A |  | 100% |  | 2024-09-27 | 2024-09-27 | 0d |  |  |  | start no earlier than 2024-09-27 |  | SI Test | SIT |  | 6.1 | Complete | Heath Thomas | COMPLETE |  |  |  |  |  |  |  |
| 1422 | 1.4.1.4.8.6.2 | Review implementation with SRO |  | 1d? | 2024-09-30 A | 2024-09-30 A |  | 100% |  | 2024-09-30 | 2024-09-30 | 0d |  |  |  | start no earlier than 2024-09-30 |  | SI Test | SIT |  | 6.1 | Complete | Heath Thomas | COMPLETE |  |  |  |  |  |  |  |
| 1423 | 1.4.1.4.8.6.3 | LDP Review - ADO User Guide, Training Materials |  | 5d | 2024-09-09 A | 2024-09-13 A |  | 100% |  | 2024-09-09 | 2024-09-13 | 0d |  |  |  | start no earlier than 2024-09-09 |  | SI Test | SIT |  | 6.1 | Complete | Heath Thomas | COMPLETE |  |  |  |  |  |  |  |
| 1424 | 1.4.1.4.8.6.4 | SRO Review - ADO User Guide, Training Materials |  | 1d? | 2024-09-30 A | 2024-09-30 A |  | 100% |  | 2024-09-30 | 2024-09-30 | 0d |  |  |  | start no earlier than 2024-09-30 |  | SI Test | SIT |  | 6.1 | Complete | Heath Thomas | COMPLETE |  |  |  |  |  |  |  |
| 1425 | 1.4.1.4.8.6.5 | LDP Review - Config doc |  | 1d? | 2024-09-30 A | 2024-09-30 A |  | 100% |  | 2024-09-30 | 2024-09-30 | 0d |  |  |  | start no earlier than 2024-09-30 |  | SI Test | SIT |  | 6.1 | Complete | Heath Thomas | COMPLETE |  |  |  |  |  |  |  |
| 1426 | 1.4.1.4.8.6.6 | SRO Review - Config doc |  | 1d? | 2024-09-30 A | 2024-09-30 A |  | 100% |  | 2024-09-30 | 2024-09-30 | 0d |  |  |  | start no earlier than 2024-09-30 |  | SI Test | SIT |  | 6.1 | Complete | Heath Thomas | COMPLETE |  |  |  |  |  |  |  |
| 1427 | 1.4.1.4.8.6.7 | SRO Sign-off of all changes |  | 1d? | 2024-10-03 A | 2024-10-03 A |  | 100% |  | 2024-10-03 | 2024-10-03 | 0d |  |  |  | start no earlier than 2024-10-03 |  | SI Test | SIT |  | 6.1 | Complete | Heath Thomas | COMPLETE |  |  |  |  |  |  |  |
| 1428 | 1.4.1.4.8.7 | **Azure DevOps Changes - Final Implementation** |  | 1d? | 2024-10-03 A | 2024-10-03 A |  | 100% |  | 2024-10-03 | 2024-10-03 | 0d |  |  |  |  |  | SI Test | SIT | -701.67 | 6.1 | Overdue Start | Heath Thomas |  |  |  |  |  |  |  |  |
| 1429 | 1.4.1.4.8.7.1 | Final task rollout |  | 1d? | 2024-10-03 A | 2024-10-03 A |  | 100% |  | 2024-10-03 | 2024-10-03 | 0d |  |  |  | start no earlier than 2024-10-03 |  | SI Test | SIT |  | 6.1 | Complete | Heath Thomas | COMPLETE |  |  |  |  |  |  |  |
| 1430 | 1.4.1.4.8.7.2 | ADO Training Drop-in Session ahead of Cycle 3 |  | 1d? | 2024-10-03 A | 2024-10-03 A |  | 100% |  | 2024-10-03 | 2024-10-03 | 0d |  |  |  | start no earlier than 2024-10-03 |  | SI Test | SIT |  | 6.1 | Complete | Heath Thomas | COMPLETE |  |  |  |  |  |  |  |
| 1431 | 1.4.2 | **SIT Execution** |  | 804d? | 2022-10-31 A | 2025-11-27 |  | 31% | 554.98d? | 2022-10-31 | 2025-11-27 | 390d | 2023-10-30 | 2025-04-25 | 540d |  | -0 | N/A | SIT |  | 5.0 |  | N/A |  | N/A | Systems Integration Testing (SIT) | SITAG |  |  |  |  |
| 1432 | 1.4.2.1 | System Integration Testing Start (M9) | milestone | 0d | 2023-10-30 A | 2023-10-30 A | 672FS+5d, 586 | 100% |  | 2023-10-30 | 2023-10-30 | 0d | 2023-10-30 | 2023-10-30 |  | must start on 2023-10-30 |  | CPT | SIT |  | 5.11 | Complete |  | COMPLETE | PMO | Systems Integration Testing (SIT) | PSG | MHHS-ART071 | T1-TE-1000 | T1 |  |
| 1433 | 1.4.2.2 | **SIT Component Integration Testing** |  | 96d | 2023-10-30 A | 2024-03-11 A |  | 100% |  | 2023-10-30 | 2024-03-11 | 95d | 2023-10-30 | 2024-03-08 |  |  |  | N/A | SIT |  | 5.0 |  | N/A |  | N/A | Systems Integration Testing (SIT) | SITAG |  |  |  | D24A - Industry Integration Test Completion Report |
| 1434 | 1.4.2.2.1 | SIT Component Integration Testing Start | milestone | 0d | 2023-10-30 A | 2023-10-30 A | 1432 | 100% |  | 2023-10-30 | 2023-10-30 | 0d | 2023-10-30 | 2023-10-30 |  |  |  | SI Test | SIT |  | 5.11 | Complete |  | COMPLETE | PP | Systems Integration Testing (SIT) |  |  |  |  |  |
| 1435 | 1.4.2.2.2 | Component Integration Testing Interval 1 Start | milestone | 0d | 2023-10-30 A | 2023-10-30 A | 672SS+1d, 593, 597, 601, 114 | 100% |  | 2023-10-30 | 2023-10-30 | 0d | 2023-10-30 | 2023-10-30 |  |  |  | SI Test | SIT |  | 5.11 | Complete |  | COMPLETE | PP | Systems Integration Testing (SIT) | SITAG | MHHS-ART071 | T3-TE-0060 | T3 |  |
| 1436 | 1.4.2.2.3 | Component Integration Testing Interval 2 Start | milestone | 0d | 2023-11-13 A | 2023-11-13 A | 699SS+5d, 593, 601, 597, 114 | 100% |  | 2023-11-13 | 2023-11-13 | 0d | 2023-11-13 | 2023-11-13 |  |  |  | SI Test | SIT |  | 5.12 | Complete |  | COMPLETE | PP | Systems Integration Testing (SIT) | SITAG |  | T3-TE-0061 | T3 |  |
| 1437 | 1.4.2.2.4 | Component Integration Testing Interval 3 Start | milestone | 0d | 2023-11-27 A | 2023-11-27 A | 731SS+5d, 593, 597, 601, 114 | 100% |  | 2023-11-27 | 2023-11-27 | 0d | 2023-11-27 | 2023-11-27 |  |  |  | SI Test | SIT |  | 5.0 | Complete |  | COMPLETE | PP | Systems Integration Testing (SIT) | SITAG |  | T3-TE-0062 | T3 |  |
| 1438 | 1.4.2.2.5 | Component Integration Testing Interval 4 Start | milestone | 0d | 2023-12-11 A | 2023-12-11 A | 763SS+5d, 593, 597, 601, 114 | 100% |  | 2023-12-11 | 2023-12-11 | 0d | 2023-12-11 | 2023-12-11 |  |  |  | SI Test | SIT |  | 5.0 | Complete |  | COMPLETE | PP | Systems Integration Testing (SIT) | SITAG |  | T3-TE-0063 | T3 |  |
| 1439 | 1.4.2.2.6 | Component Integration Testing Interval 5 Start | milestone | 0d | 2024-01-15 A | 2024-01-15 A | 795SS+5d, 593, 597, 601, 114 | 100% |  | 2024-01-15 | 2024-01-15 | 0d | 2024-01-15 | 2024-01-15 |  |  |  | SI Test | SIT |  | 5.0 | Complete |  | COMPLETE | PP | Systems Integration Testing (SIT) | SITAG |  | T3-TE-0064 | T3 |  |
| 1440 | 1.4.2.2.7 | Component Integration Testing Interval 6 Start | milestone | 0d | 2024-01-29 A | 2024-01-29 A | 593, 597, 601, 827, 114, 639 | 100% |  | 2024-01-29 | 2024-01-29 | 0d | 2024-01-29 | 2024-01-29 |  | must start on 2024-01-29 |  | SI Test | SIT |  | 5.0 | Complete |  | COMPLETE | PP | Systems Integration Testing (SIT) | SITAG |  | T3-TE-0065 | T3 |  |
| 1441 | 1.4.2.2.8 | SIT Component Integration Testing Execution |  | 85d | 2023-10-30 A | 2024-02-23 A | 1435SS | 100% |  | 2023-10-30 | 2024-02-23 | 85d | 2023-10-30 | 2024-02-23 |  | must start on 2023-10-30 |  | SI Test | SIT |  | 5.0 | Complete |  | COMPLETE | PP | Systems Integration Testing (SIT) |  |  |  |  | D24A - Industry Integration Test Completion Report |
| 1442 | 1.4.2.2.9 | SIT Component Integration Testing End (incl. confirmation that PPs have submitted their Test Completion Reports to Programme for assurance) | milestone | 0d | 2024-02-23 A | 2024-02-23 A | 1441FF | 100% |  | 2024-02-23 | 2024-02-23 | 0d | 2024-02-23 | 2024-02-23 |  |  |  | SI Test | SIT |  | 5.19 | Complete |  | COMPLETE | PP | Systems Integration Testing (SIT) | SITAG | MHHS-ART074 | T3-TE-0032 | T3 |  |
| 1443 | 1.4.2.2.10 | Assurance of PPs Test Completion Reports |  | 30d | 2024-01-22 A | 2024-03-01 A | 1442FF+5d | 100% |  | 2024-01-22 | 2024-03-01 | 30d | 2024-01-22 | 2024-03-01 |  |  |  | SI Test | SIT |  | 5.19 | Complete |  | COMPLETE | PP | Systems Integration Testing (SIT) |  |  |  |  |  |

| ID | WBS | Task | Type | Duration | Start | Finish | Predecessors | Complete | Remaining | Baseline start | Baseline finish | Baseline duration | Baseline 1 start | Baseline 1 finish | Total slack | Free slack | Baseline cost | Responsible | Involved | Text9 | Update Version | MHHS Resource Name | MHHS Programme Phase | Sched Status | RAG | Artefact ID | Milestone ID | Text29 | Tier | Future RAG | Task Status |
| --- | --- | --- | --- | --- | --- | --- | --- | --- | --- | --- | --- | --- | --- | --- | --- | --- | --- | --- | --- | --- | --- | --- | --- | --- | --- | --- | --- | --- | --- | --- | --- |
| 1444 | 1.4.2.2.11 | **SIT CI Test Completion Report** |  | 18d | 2024-02-07 A | 2024-03-01 A |  | 100% |  | 2024-02-07 | 2024-03-01 | 18d | 2024-02-07 | 2024-03-01 |  |  |  | N/A | N/A | SIT | 5.0 | N/A | Systems Integration Testing (SIT) |  |  |  |  |  |  |  |  |
| 1445 | 1.4.2.2.11.1 | Develop document |  | 13d | 2024-02-07 A | 2024-02-23 A | 1442FF | 100% |  | 2024-02-07 | 2024-02-23 | 13d | 2024-02-07 | 2024-02-23 |  |  |  | SI Test |  | SIT | 5.19 |  | Systems Integration Testing (SIT) | Complete | COMPLETE |  |  |  |  |  |  |
| 1446 | 1.4.2.2.11.2 | Review & agree document |  | 5d | 2024-02-26 A | 2024-03-01 A | 1445, 1443FF | 100% |  | 2024-02-26 | 2024-03-01 | 5d | 2024-02-26 | 2024-03-01 |  |  |  | SI Test | PP,IPA | SIT | 5.19 |  | Systems Integration Testing (SIT) | Complete | COMPLETE |  |  |  |  |  |  |
| 1447 | 1.4.2.2.12 | SIT Component Integration Testing Test Completion Report Approved | milestone | 0d | 2024-03-11 A | 2024-03-11 A | 1446FS+6d | 100% |  | 2024-03-11 | 2024-03-11 | 0d | 2024-03-08 | 2024-03-08 |  |  |  | SI Test | PP | SIT | 5.18 |  | Systems Integration Testing (SIT) | Complete | COMPLETE | MHHS-ART074 | T2-TE-0600 | SITAG | T2 |  |  |
| 1448 | 1.4.2.3 | **SIT - Minimum Viable Cohort (MVC)** |  | 735d? | 2022-10-31 A | 2025-08-22 |  | 28% | 528.28d? | 2022-10-31 | 2025-08-22 | 240d | 2024-03-11 | 2025-02-07 | 609d |  | -0 | N/A | N/A | SIT | 5.0 | N/A | Systems Integration Testing (SIT) |  |  |  |  | SITAG |  |  |  |
| 1449 | 1.4.2.3.1 | **SIT Functional Testing (MVC)** |  | 730d? | 2022-10-31 A | 2025-08-15 |  | 40% | 439.11d? | 2022-10-31 | 2025-08-15 | 225d | 2024-03-11 | 2025-01-17 | 614d |  |  | N/A | N/A | SIT | 5.0 | N/A | Systems Integration Testing (SIT) |  |  |  |  |  |  |  |  |
| 1450 | 1.4.2.3.1.1 | SIT Functional Testing Start | milestone | 0d | 2024-03-11 A | 2024-03-11 A | 1447, 957FS+5d, 834, 842, 843, 844, 851 | 100% |  | 2024-03-11 | 2024-03-11 | 0d | 2024-03-11 | 2024-03-11 |  |  |  | SI Test | PP | SIT | 6.1 |  | Systems Integration Testing (SIT) | Complete | COMPLETE | MHHS-ART073 | T3-TE-0034 | SITAG | T3 |  |  |
| 1451 | 1.4.2.3.1.2 | **SIT Functional Testing Execution (Minimum Viable Cohort)** |  | 730d? | 2022-10-31 A | 2025-08-15 |  | 40% | 439.11d? | 2022-10-31 | 2025-08-15 | 225d | 2024-03-11 | 2025-01-17 | 614d |  |  | N/A | N/A | SIT | 5.0 | N/A | Systems Integration Testing (SIT) |  |  |  |  |  |  | D24C - E2E Test Completion Report | M10 |
| 1452 | 1.4.2.3.1.2.1 | **Cycle 1 (Full Cycle)** |  | 70d | 2024-03-11 A | 2024-06-14 A |  | 100% |  | 2024-03-11 | 2024-06-14 | 90d | 2024-03-11 | 2024-07-12 |  |  |  | N/A | N/A | SIT | 5.0 | N/A | Systems Integration Testing (SIT) |  |  |  |  |  |  |  |  |
| 1453 | 1.4.2.3.1.2.1.1 | Test Execution |  | 55d | 2024-03-11 A | 2024-05-24 A | 1450SS-1d, 921 | 100% |  | 2024-03-11 | 2024-05-24 | 80d | 2024-03-11 | 2024-06-28 |  |  |  | PP | SI Test | SIT | 5.0 |  | Systems Integration Testing (SIT) | Complete | COMPLETE |  |  |  |  |  |  |
| 1454 | 1.4.2.3.1.2.1.2 | Defect resolution, assurance, review, data & environments maintenance |  | 15d | 2024-05-27 A | 2024-06-14 A | 1453 | 100% |  | 2024-05-27 | 2024-06-14 | 10d | 2024-07-01 | 2024-07-12 |  |  |  | SI Test | PP | SIT | 5.0 |  | Systems Integration Testing (SIT) | Complete | COMPLETE |  |  |  |  |  |  |
| 1455 | 1.4.2.3.1.2.2 | **Cycle 2 (Defect retests and targeted regression testing)** |  | 80d | 2024-06-17 A | 2024-10-04 A |  | 100% |  | 2024-06-17 | 2024-10-04 | 50d | 2024-07-15 | 2024-09-20 |  |  |  | N/A | N/A | SIT | 5.0 | N/A | Systems Integration Testing (SIT) |  |  |  |  |  |  |  |  |
| 1456 | 1.4.2.3.1.2.2.1 | Test Execution |  | 70d | 2024-06-17 A | 2024-09-20 A | 1454, 926 | 100% |  | 2024-06-17 | 2024-09-20 | 40d | 2024-07-15 | 2024-09-06 |  |  |  | PP | SI Test | SIT | 5.0 | Roger Robar | Systems Integration Testing (SIT) | Complete | COMPLETE |  |  |  |  |  |  |
| 1457 | 1.4.2.3.1.2.2.2 | Defect resolution, assurance, review, data & environments maintenance |  | 10d | 2024-09-23 A | 2024-10-04 A | 1456 | 100% |  | 2024-09-23 | 2024-10-04 | 10d | 2024-09-09 | 2024-09-20 |  |  |  | SI Test | PP | SIT | 5.0 | Roger Robar | Systems Integration Testing (SIT) | Complete | COMPLETE |  |  |  |  |  |  |
| 1458 | 1.4.2.3.1.2.3 | **SIT Functional Testing back-up progress risk-assessment** |  | 0d | 2022-10-31 | 2022-10-31 |  |  |  | 2022-10-31 | 2022-10-31 | 20d | 2024-09-23 | 2024-10-18 | 1344d |  |  | N/A | N/A | SIT | 5.31 | N/A | Systems Integration Testing (SIT) |  |  |  |  |  |  |  |  |
| 1459 | 1.4.2.3.1.2.3.1 | Back-up risk-assessment of SIT Functional progress to assess whether Qualification Execution can start early | inactive | 15d | 2024-10-07 | 2024-10-25 | 1457 |  |  | 2024-10-07 | 2024-10-25 | 15d | 2024-09-23 | 2024-10-11 | 819d | 0d |  | SI Test | Code Bodies,PP,IPA | SIT | 5.31 | Nicola Farley | Systems Integration Testing (SIT) |  | GREEN |  |  |  |  |  | -50.67 |
| 1460 | 1.4.2.3.1.2.3.2 | Back-up SITAG decision on early Qualification Testing Execution start | milestone, inactive | 0d | 2024-11-01 | 2024-11-01 | 1459FS+5d |  |  | 2024-11-01 | 2024-11-01 | 0d | 2024-10-18 | 2024-10-18 | 819d |  |  | SI Test | Code Bodies,PP,IPA | SIT | 5.31 | Nicola Farley | Systems Integration Testing (SIT) |  | GREEN |  |  | QAG | T3 |  | -25.29 |
| 1461 | 1.4.2.3.1.2.4 | **Cycle 3 (Defect retests and targeted regression testing)** |  | 105d? | 2024-10-21 A | 2025-03-14 |  | 17% | 87.02d? | 2024-10-21 | 2025-03-14 | 30d | 2024-09-23 | 2024-11-01 |  |  |  | N/A | N/A | SIT | 5.0 | N/A | Systems Integration Testing (SIT) |  |  |  |  |  |  |  |  |
| 1462 | 1.4.2.3.1.2.4.1 | Sprint 5 |  | 10d? | 2024-10-21 A | 2024-11-01 A | 140SS-1d | 100% |  | 2024-10-21 | 2024-11-01 | 0d |  |  |  |  |  |  |  | SIT | 6.0 | Roger Robar |  | Complete | COMPLETE |  |  |  |  |  |  |
| 1463 | 1.4.2.3.1.2.4.2 | Sprint 6 |  | 10d? | 2024-11-04 A | 2024-11-15 A | 1462 | 100% |  | 2024-11-04 | 2024-11-15 | 0d |  |  |  |  |  |  |  | SIT | 6.0 | Roger Robar |  | Complete | COMPLETE |  |  |  |  |  |  |
| 1464 | 1.4.2.3.1.2.4.3 | Sprint 7 |  | 10d? | 2024-11-18 A | 2024-11-29 | 1463 | 50% | 5d? | 2024-11-18 | 2024-11-29 | 0d |  |  | 5d | 0d |  |  |  | SIT | 6.0 | Roger Robar |  | Green | GREEN |  |  |  |  |  |  |
| 1465 | 1.4.2.3.1.2.4.4 | Sprint 8 |  | 15d? | 2024-12-02 | 2024-12-20 | 1464 |  |  | 2024-12-02 | 2024-12-20 | 0d |  |  | 5d | 0d |  |  |  | SIT | 6.0 | Roger Robar |  | Green | GREEN |  |  |  |  |  | 5.33 |
| 1466 | 1.4.2.3.1.2.4.5 | Christmas downtime |  | 10d? | 2024-12-23 | 2025-01-03 | 1465 |  |  | 2024-12-23 | 2025-01-03 | 0d |  |  | 5d | 0d |  |  |  | SIT | 6.0 | Roger Robar |  | Green | GREEN |  |  |  |  |  | 26.33 |
| 1467 | 1.4.2.3.1.2.4.6 | Sprint 9 |  | 10d? | 2025-01-06 | 2025-01-17 | 1466 |  |  | 2025-01-06 | 2025-01-17 | 0d |  |  | 5d | 0d |  |  |  | SIT | 6.0 | Roger Robar |  | Green | GREEN |  |  |  |  |  | 40.33 |
| 1468 | 1.4.2.3.1.2.4.7 | Sprint 10 |  | 10d? | 2025-01-20 | 2025-01-31 | 1467 |  |  | 2025-01-20 | 2025-01-31 | 0d |  |  | 5d | 0d |  |  |  | SIT | 6.0 | Roger Robar |  | Green | GREEN |  |  |  |  |  | 54.33 |
| 1469 | 1.4.2.3.1.2.4.8 | Sprint 11 |  | 10d? | 2025-02-03 | 2025-02-14 | 1468 |  |  | 2025-02-03 | 2025-02-14 | 0d |  |  | 5d | 0d |  |  |  | SIT | 6.0 | Roger Robar |  | Green | GREEN |  |  |  |  |  | 68.33 |
| 1470 | 1.4.2.3.1.2.4.9 | Sprint 12 |  | 10d? | 2025-02-17 | 2025-02-28 | 1469 |  |  | 2025-02-17 | 2025-02-28 | 0d |  |  | 5d | 0d |  |  |  | SIT | 6.0 | Roger Robar |  | Green | GREEN |  |  |  |  |  | 82.33 |
| 1471 | 1.4.2.3.1.2.4.10 | Sprint 13 (RTTM Gap Analysis + CR056) |  | 10d? | 2025-03-03 | 2025-03-14 | 1470 |  |  | 2025-03-03 | 2025-03-14 | 0d |  |  | 5d | 0d |  |  |  | SIT | 6.0 | Roger Robar |  | Green | GREEN |  |  |  |  |  | 96.33 |
| 1472 | 1.4.2.3.1.2.4.11 | Sprint 14 (RTTM Gap Analysis + CR056) |  | 10d? | 2025-03-17 | 2025-03-28 | 1471 |  |  | 2025-03-17 | 2025-03-28 | 0d |  |  | 5d | 0d |  |  |  | SIT | 6.1 | Roger Robar |  | Green | GREEN |  |  |  |  |  | 110.33 |
| 1473 | 1.4.2.3.1.2.4.12 | Sprint 15 (Contingency 1) |  | 10d? | 2025-03-31 | 2025-04-11 | 1472 |  |  | 2025-03-31 | 2025-04-11 | 0d |  |  | 5d | 0d |  |  |  | SIT | 6.1 | Roger Robar |  | Green | GREEN |  |  |  |  |  | 124.33 |
| 1474 | 1.4.2.3.1.2.4.13 | Sprint 16 (Contingency 2) |  | 10d? | 2025-04-14 | 2025-04-25 | 1473 |  |  | 2025-04-14 | 2025-04-25 | 0d |  |  | 5d | 0d |  |  |  | SIT | 6.1 | Roger Robar |  | Green | GREEN |  |  |  |  |  | 138.33 |
| 1475 | 1.4.2.3.1.2.4.14 | SIT Functional Cycle 3 Complete |  | 1d? | 2025-04-28 | 2025-04-28 | 1474 |  |  |  |  |  |  |  | 693d |  |  |  |  |  | 6.13 |  |  | No BL | GREEN |  | T2-TE-1150 |  |  |  | 152.33 |
| 1476 | 1.4.2.3.1.2.4.15 | Defect resolution, assurance, review, data & environments maintenance |  | 10d | 2024-10-21 | 2024-11-01 |  |  |  | 2024-10-21 | 2024-11-01 | 10d | 2024-10-21 | 2024-11-01 | 819d |  |  | SI Test | PP | SIT | 6.1 | Roger Robar | Systems Integration Testing (SIT) | Overdue Start | RED |  |  |  |  |  | -36.67 |

Notes:
- 1459: Action: 5/12 - LC said change name from his to nicola and check dates based on new start date for non sit ldso testing
- 1460: 15/8/24: Milestone to be removed as no longer applicable / Guidance: 13/8/24: To be removed because SIT has not made sufficient progress to allow early quaifation test start. 22/8/24: Approved at QAG on 22/8/24 to be removed
- 1475: 27/11/24 - New milestone added by Programme, awaiting formal SITAG approval.

| ID | WBS | Task | Type | Duration | Start | Finish | Predecessors | Complete | Remaining | Actual start | Baseline start | Baseline finish | Baseline duration | Baseline 1 start | Baseline 1 finish | Total slack | Free slack | Constraint | Text9 | Task Status | Update Version | Sched Status | MHHS Resource Name | RAG | Milestone ID | Responsible | Involved | MHHS Programme Phase | Artefact ID | Text29 | Tier |
| --- | --- | --- | --- | --- | --- | --- | --- | --- | --- | --- | --- | --- | --- | --- | --- | --- | --- | --- | --- | --- | --- | --- | --- | --- | --- | --- | --- | --- | --- | --- | --- |
| 1477 | 1.4.2.3.1.2.5 | **SIT Functional Settlement Testing** |  | 230d? | 2024-06-17 | 2025-05-02 |  | 24% | 174.48d? | 2024-10-07 | 2024-06-17 | 2025-05-02 | 0d |  |  |  |  |  | SIT | -685.67 | 6.12 | Overdue Start | Stuart Scott | RED |  |  |  |  |  |  |  |
| 1478 | 1.4.2.3.1.2.5.1 | SIT-B Settlement Testing Cycle 2 |  | 70d | 2025-01-06 | 2025-04-11 | 1488FS+10d |  |  |  | 2024-06-17 | 2024-09-20 | 0d |  |  | 704d |  | start no earlier than 2024-06-17 | SIT | 40.33 | 6.12 | Red | Stuart Scott | RED |  |  |  |  |  |  |  |
| 1479 | 1.4.2.3.1.2.5.2 | **SIT-B Settlement Testing Cycle 3** |  | 55d? | 2024-10-07 A | 2024-12-20 | 1338 | 64% | 20d? |  | 2024-10-07 | 2024-12-20 | 0d |  |  | 61d | 0d |  | SIT | -24.67 | 6.12 | Overdue Start | Stuart Scott | GREEN |  |  |  |  |  |  |  |
| 1480 | 1.4.2.3.1.2.5.2.1 | Sprint 5 |  | 20d? | 2024-10-07 A | 2024-11-01 A |  | 100% |  |  | 2024-10-07 | 2024-11-01 | 0d |  |  |  |  |  | SIT |  | 6.12 | Complete | Stuart Scott | COMPLETE |  |  |  |  |  |  |  |
| 1481 | 1.4.2.3.1.2.5.2.2 | Sprint 5 Review (Flexibility Window Checkpoint) | milestone | 0d | 2024-11-04 A | 2024-11-04 A | 1480SS+21d | 100% |  |  | 2024-11-04 | 2024-11-04 | 0d |  |  |  |  |  | SIT |  | 6.12 | Complete | Stuart Scott | COMPLETE |  |  |  |  |  |  |  |
| 1482 | 1.4.2.3.1.2.5.2.3 | Sprint 6 |  | 10d? | 2024-11-04 A | 2024-11-15 A | 1480 | 100% |  |  | 2024-11-04 | 2024-11-15 | 0d |  |  |  |  |  | SIT |  | 6.12 | Complete | Stuart Scott | COMPLETE |  |  |  |  |  |  |  |
| 1483 | 1.4.2.3.1.2.5.2.4 | Sprint 6 Review (Pre Christmas Contingency Decision Point) | milestone | 0d | 2024-11-18 A | 2024-11-18 A | 1482SS+11d | 100% |  |  | 2024-11-18 | 2024-11-18 | 0d |  |  |  |  |  | SIT |  | 6.12 | Complete | Stuart Scott | COMPLETE |  |  |  |  |  |  |  |
| 1484 | 1.4.2.3.1.2.5.2.5 | Sprint 7 |  | 10d? | 2024-11-18 A | 2024-11-29 | 1482 | 50% | 5d? |  | 2024-11-18 | 2024-11-29 | 0d |  |  | 61d | 0d |  | SIT |  | 6.12 | Green | Stuart Scott | GREEN |  |  |  |  |  |  |  |
| 1485 | 1.4.2.3.1.2.5.2.6 | Sprint 7 Review (Post Christmas Contingency Decision Point) | milestone | 0d | 2024-12-02 | 2024-12-02 | 1484SS+11d |  |  |  | 2024-12-02 | 2024-12-02 | 0d |  |  | 75d |  |  | SIT | 5.71 | 6.12 | Green | Stuart Scott | GREEN |  |  |  |  |  |  |  |
| 1486 | 1.4.2.3.1.2.5.2.7 | Sprint 8 |  | 15d | 2024-12-02 | 2024-12-20 | 1484 |  |  |  | 2024-12-02 | 2024-12-20 | 0d |  |  | 61d | 0d |  | SIT | 5.33 | 6.12 | Green | Stuart Scott | GREEN |  |  |  |  |  |  |  |
| 1487 | 1.4.2.3.1.2.5.2.8 | Sprint 8 Review | milestone | 0d | 2024-12-13 | 2024-12-13 | 1486SS+10d |  |  |  | 2024-12-13 | 2024-12-13 | 0d |  |  | 66d |  |  | SIT | 16.71 | 6.12 | Green | Stuart Scott | GREEN |  |  |  |  |  |  |  |
| 1488 | 1.4.2.3.1.2.5.2.9 | End of Settlement Testing Cycle 3 | milestone | 0d | 2024-12-20 | 2024-12-20 | 1486SS+15d |  |  |  | 2024-12-20 | 2024-12-20 | 0d |  |  | 61d | 0d |  | SIT | 23.71 | 6.12 | Green | Stuart Scott | AMBER | T3-TE-0140 |  |  |  |  |  |  |
| 1489 | 1.4.2.3.1.2.5.3 | SIT-A CoS Settlement Testing |  | 20d? | 2025-05-19 | 2025-06-13 | 1378 |  |  |  | 2025-05-19 | 2025-06-13 | 0d |  |  | 5d | 0d |  | SIT | 173.33 | 6.12 | Green | Stuart Scott | GREEN |  |  |  |  |  |  |  |
| 1490 | 1.4.2.3.1.2.6 | **SIT Functional MVC Regression Testing (code freeze)** |  | 725d? | 2022-10-31 | 2025-08-08 |  |  |  |  | 2025-06-16 | 2025-08-08 | 45d | 2024-11-04 | 2025-01-03 | 619d |  |  | SIT | 84.33 | 5.0 | Red |  |  |  | PP | SI Test | Systems Integration Testing (SIT) |  |  |  |
| 1491 | 1.4.2.3.1.2.6.1 | Regression Test Execution Start |  | 1d? | 2022-10-31 | 2022-10-31 |  |  |  |  |  |  |  |  |  | 1343d |  |  |  | -757.67 | 6.0 | Overdue Start |  | RED | T2-TE-XXXX |  |  |  |  |  |  |
| 1492 | 1.4.2.3.1.2.6.2 | Regression Sprint 1 |  | 10d? | 2025-06-16 | 2025-06-27 | 1489, 1372 |  |  |  | 2025-06-16 | 2025-06-27 | 0d |  |  | 5d | 0d |  | SIT | 201.33 | 6.0 | Green | Roger Robar | GREEN |  |  |  |  |  |  |  |
| 1493 | 1.4.2.3.1.2.6.3 | Regression Sprint 2 |  | 10d | 2025-06-30 | 2025-07-11 | 1492 |  |  |  | 2025-06-30 | 2025-07-11 | 0d |  |  | 5d | 0d |  | SIT | 215.33 | 6.0 | Green | Roger Robar | GREEN |  |  |  |  |  |  |  |
| 1494 | 1.4.2.3.1.2.6.4 | Regression Sprint 3 |  | 15d | 2025-07-14 | 2025-08-01 | 1493 |  |  |  | 2025-07-14 | 2025-08-01 | 0d |  |  | 5d | 0d |  | SIT | 229.33 | 6.0 | Green | Roger Robar | GREEN |  |  |  |  |  |  |  |
| 1495 | 1.4.2.3.1.2.6.5 | SIT Functional Testing End (Minimum Viable Cohort) (incl. confirmation that PPs have submitted their Test Completion Reports to Programme for assurance) | milestone | 0d | 2025-08-01 | 2025-08-01 | 1494 |  |  |  | 2025-08-01 | 2025-08-01 | 0d | 2025-01-03 | 2025-01-03 | 5d | 0d | start no earlier than 2025-03-14 | SIT | 247.71 | 6.1 | Green | Roger Robar | GREEN | T3-TE-0046 | SI Test | PP | Systems Integration Testing (SIT) | MHHS-ART072 | SITAG | T3 |
| 1496 | 1.4.2.3.1.2.6.6 | Assurance of PPs Test Completion Reports |  | 30d | 2025-06-30 | 2025-08-08 | 1495FF+5d |  |  |  | 2025-06-30 | 2025-08-08 | 30d | 2024-12-02 | 2025-01-10 | 5d | 0d |  | SIT | 215.33 | 6.1 | Green | Roger Robar | GREEN |  | SI Test | PP | Systems Integration Testing (SIT) |  |  |  |
| 1497 | 1.4.2.3.1.2.7 | **SIT Functional Test Completion Report (Minimum Viable Cohort)** |  | 25d | 2025-07-14 | 2025-08-15 |  |  |  |  | 2025-07-14 | 2025-08-15 | 20d | 2024-12-16 | 2025-01-10 | 5d |  |  | SIT |  | 6.1 |  | N/A |  |  | N/A | N/A | Systems Integration Testing (SIT) |  |  |  |
| 1498 | 1.4.2.3.1.2.7.1 | Develop document |  | 15d | 2025-07-14 | 2025-08-01 | 1495FF |  |  |  | 2025-07-14 | 2025-08-01 | 15d | 2024-12-16 | 2025-01-03 | 5d | 0d |  | SIT | 229.33 | 6.1 | Green | Roger Robar | GREEN |  | SI Test |  | Systems Integration Testing (SIT) |  |  |  |
| 1499 | 1.4.2.3.1.2.7.2 | Review & agree document |  | 5d | 2025-08-04 | 2025-08-08 | 1498, 1496FF |  |  |  | 2025-08-04 | 2025-08-08 | 5d | 2025-01-06 | 2025-01-10 | 5d | 0d |  | SIT | 250.33 | 6.1 | Green | Roger Robar | GREEN |  | SI Test | PP,IPA | Systems Integration Testing (SIT) |  |  |  |
| 1500 | 1.4.2.3.1.2.7.3 | SIT Functional Testing Test Completion Report (Minimum Viable Cohort) Approved | milestone | 0d | 2025-08-15 | 2025-08-15 | 1499FF+5d |  |  |  | 2025-08-15 | 2025-08-15 | 0d | 2025-01-17 | 2025-01-17 | 5d | 0d |  | SIT | 261.71 | 6.1 | Green | Roger Robar | GREEN | T2-TE-0850 | SI Test | PP | Systems Integration Testing (SIT) | MHHS-ART072 | SITAG | T2 |

Notes:
- 1488: 25/11/24 - New milestone added by Programme, awaiting formal SITAG approval. Progress is being made, but at a slower velocity than expected, so date is considered at risk.
- 1491: 27/11/24 - Programme is working to add dependencies and assign milestone ID which will go to SITAG for approval.

| ID | WBS | Task | Type | Duration | Start | Finish | Predecessors | Complete | Remaining | Actual start | Actual finish | Baseline start | Baseline finish | Baseline duration | Baseline 1 start | Baseline 1 finish | Total slack | Free slack | Constraint | Baseline cost | Text9 | Task Status | Sched Status | MHHS Resource Name | Update Version | RAG | Responsible | Involved | MHHS Programme Phase | Text29 | Milestone ID |
| --- | --- | --- | --- | --- | --- | --- | --- | --- | --- | --- | --- | --- | --- | --- | --- | --- | --- | --- | --- | --- | --- | --- | --- | --- | --- | --- | --- | --- | --- | --- | --- |
| 1501 | 1.4.2.3.2 | **Helix E2E Settlement Testing** |  | 65d | 2025-01-06 | 2025-04-04 |  |  |  |  |  | 2025-01-06 | 2025-04-04 | 0d |  |  | 709d |  |  |  | SIT | -689.67 | Overdue Start | Helix |  |  |  |  |  |  |  |
| 1502 | 1.4.2.3.2.1 | Helix E2E Settlement Testing Execution |  | 65d | 2025-01-06 | 2025-04-04 | 1479FS+10d |  |  |  |  | 2025-01-06 | 2025-04-04 | 0d |  |  | 709d | 0d |  |  | SIT | 40.33 | Green | Helix | 6.0 | GREEN |  |  |  |  |  |
| 1503 | 1.4.2.3.2.2 | Helix E2E Settlement Testing Execution Complete | milestone | 0d | 2025-04-04 | 2025-04-04 | 1502 |  |  |  |  | 2025-04-04 | 2025-04-04 | 0d |  |  | 709d |  |  |  | SIT | 128.71 | Green | Helix | 6.0 | GREEN |  |  |  |  |  |
| 1504 | 1.4.2.3.2.3 | MHHSP Helix E2E Testing Assurance |  | 65d | 2025-01-06 | 2025-04-04 | 1479FS+10d |  |  |  |  | 2025-01-06 | 2025-04-04 | 0d |  |  | 709d | 0d |  |  | SIT | 40.33 | Green | Helix | 6.0 | GREEN |  |  |  |  |  |
| 1505 | 1.4.2.3.2.4 | MHHSP Helix E2E Testing Assurance Complete | milestone | 0d | 2025-04-04 | 2025-04-04 | 1504 |  |  |  |  | 2025-04-04 | 2025-04-04 | 0d |  |  | 709d |  |  |  | SIT | 128.71 | Green | Helix | 6.0 | GREEN |  |  |  |  |  |
| 1506 | 1.4.2.3.3 | **SIT Migration Testing (MVC)** |  | 735d? | 2022-10-31 A | 2025-08-22 |  | 44% | 415.1d? |  |  | 2024-03-11 | 2025-08-22 | 155d | 2024-06-10 | 2024-10-18 | 609d |  |  | -0 | SIT |  | Overdue | N/A | 6.0 | GREEN | N/A | N/A | Systems Integration Testing (SIT) | SITAG |  |
| 1507 | 1.4.2.3.3.1 | SIT Migration Testing Start | milestone | 0d? | 2024-03-11 | 2024-03-11 |  |  |  |  |  | 2024-03-11 | 2024-03-11 | 0d |  |  | 989d |  | start no earlier than 2024-03-11 |  | SIT | -260.67 | Overdue Start |  | 6.0 | RED |  |  |  |  |  |
| 1508 | 1.4.2.3.3.2 | **SIT Migration Testing Execution (Minimum Viable Cohort)** |  | 735d? | 2022-10-31 A | 2025-08-22 |  | 44% | 415.1d? |  |  | 2024-03-11 | 2025-08-22 | 0d |  |  | 609d |  |  |  | SIT | -685.67 | Overdue Start |  | 6.0 | RED |  |  |  | SITAG |  |
| 1509 | 1.4.2.3.3.2.1 | **Cycle 1 (Full Cycle)** |  | 70d? | 2024-03-11 A | 2024-06-14 A |  | 100% |  |  |  | 2024-03-11 | 2024-06-14 | 0d |  |  |  |  |  |  | SIT | -685.67 | Overdue Start |  | 6.0 |  |  |  |  |  |  |
| 1510 | 1.4.2.3.3.2.1.1 | Test Execution |  | 55d? | 2024-03-11 A | 2024-05-24 A |  | 100% |  |  |  |  |  |  |  |  |  |  | start no earlier than 2024-03-11 |  | SIT |  | Complete |  | 6.0 | COMPLETE |  |  |  |  |  |
| 1511 | 1.4.2.3.3.2.1.2 | Defect resolution, assurance, review, data& environments maintenance |  | 15d? | 2024-05-27 A | 2024-06-14 A |  | 100% |  |  |  |  |  |  |  |  |  |  | finish no earlier than 2024-06-14 |  | SIT |  | Complete |  | 6.0 | COMPLETE |  |  |  |  |  |
| 1512 | 1.4.2.3.3.2.2 | **Cycle 2 (Defect retests and targeted regression testing)** |  | 80d? | 2024-03-11 | 2024-06-28 |  | 100% |  | 2024-06-17 | 2024-10-04 | 2024-03-11 | 2024-06-28 | 0d |  |  |  |  |  |  | SIT | -685.67 | Overdue Start |  | 6.0 |  |  |  |  |  |  |
| 1513 | 1.4.2.3.3.2.2.1 | Test Execution |  | 70d? | 2024-06-17 A | 2024-09-20 A | 1511 | 100% |  |  |  |  |  |  |  |  |  |  | start no earlier than 2024-06-17 |  | SIT |  | Complete |  | 6.0 | COMPLETE |  |  |  |  |  |
| 1514 | 1.4.2.3.3.2.2.2 | Defect resolution, assurance, review, data & environments maintenance |  | 10d? | 2024-09-23 A | 2024-10-04 A | 1513 | 100% |  |  |  |  |  |  |  |  |  |  | finish no earlier than 2024-10-04 |  | SIT |  | Complete |  | 6.0 | COMPLETE |  |  |  |  |  |
| 1515 | 1.4.2.3.3.2.3 | **SIT Functional Testing back-up progress risk-assessment** |  | 70d? | 2024-06-17 | 2024-09-20 |  |  |  |  |  | 2024-06-17 | 2024-09-20 | 0d |  |  |  |  |  |  | SIT | -685.67 | Overdue Start |  | 6.0 | RED |  |  |  |  |  |
| 1516 | 1.4.2.3.3.2.3.1 | Back-up risk-assessment of SIT Migration progress to assess whether Qualification Execution can start early |  | 15d? | 2024-10-07 | 2024-10-25 | 1514 |  |  |  |  | 2024-10-07 | 2024-10-25 | 0d |  |  | 819d | 0d | finish no earlier than 2024-10-04 |  | SIT | -50.67 | Overdue Start |  | 6.0 | RED |  |  |  |  |  |
| 1517 | 1.4.2.3.3.2.3.2 | Back-up SITAG decision on early Qualification Testing Execution start | milestone | 0d? | 2024-11-01 | 2024-11-01 | 1516FS+5d |  |  |  |  | 2024-11-01 | 2024-11-01 | 0d |  |  | 819d |  |  |  | SIT | -25.29 | Green |  | 6.0 | RED |  |  |  |  |  |
| 1518 | 1.4.2.3.3.2.4 | **Cycle 3 (Defect retests and targeted regression testing)** |  | 650d? | 2022-10-31 A | 2025-04-25 |  | 13% | 563.97d? |  |  | 2024-10-21 | 2025-04-25 | 0d |  |  | 694d |  |  |  | SIT | -685.67 | Overdue Start | Roger Robar | 6.0 | RED |  |  |  |  |  |
| 1519 | 1.4.2.3.3.2.4.1 | Sprint 5 |  | 10d | 2024-10-21 A | 2024-11-01 A | 140FS-1d | 100% |  |  |  | 2024-10-21 | 2024-11-01 | 0d |  |  |  |  | start no earlier than 2024-10-21 |  | SIT |  | Complete | Roger Robar | 6.0 | COMPLETE |  |  |  |  |  |
| 1520 | 1.4.2.3.3.2.4.2 | Sprint 6 |  | 10d | 2024-11-04 A | 2024-11-15 | 1519 | 80% | 2d |  |  | 2024-11-04 | 2024-11-15 | 0d |  |  | 5d | 0d | start no earlier than 2024-11-04 |  | SIT |  | Green | Roger Robar | 6.0 | GREEN |  |  |  |  |  |
| 1521 | 1.4.2.3.3.2.4.3 | Sprint 7 |  | 10d | 2024-11-18 | 2024-11-29 | 1520 |  |  |  |  | 2024-11-18 | 2024-11-29 | 0d |  |  | 5d | 0d |  |  | SIT | -8.67 | Green | Roger Robar | 6.0 | GREEN |  |  |  |  |  |
| 1522 | 1.4.2.3.3.2.4.4 | Sprint 8 |  | 15d | 2024-12-02 | 2024-12-20 | 1521 |  |  |  |  | 2024-12-02 | 2024-12-20 | 0d |  |  | 5d | 0d | finish no earlier than 2024-11-15 |  | SIT | 5.33 | Green | Roger Robar | 6.0 | GREEN |  |  |  |  |  |
| 1523 | 1.4.2.3.3.2.4.5 | Christmas downtime |  | 10d | 2024-12-23 | 2025-01-03 | 1522 |  |  |  |  | 2024-12-23 | 2025-01-03 | 0d |  |  | 5d | 0d | finish no earlier than 2024-11-29 |  | SIT | 26.33 | Green | Roger Robar | 6.0 | GREEN |  |  |  |  |  |
| 1524 | 1.4.2.3.3.2.4.6 | Sprint 9 |  | 10d | 2025-01-06 | 2025-01-17 | 1523 |  |  |  |  | 2025-01-06 | 2025-01-17 | 0d |  |  | 5d | 0d | finish no earlier than 2024-12-20 |  | SIT | 40.33 | Green | Roger Robar | 6.0 | GREEN |  |  |  |  |  |
| 1525 | 1.4.2.3.3.2.4.7 | Sprint 10 |  | 10d | 2025-01-20 | 2025-01-31 | 1524 |  |  |  |  | 2025-01-20 | 2025-01-31 | 0d |  |  | 5d | 0d | finish no earlier than 2025-01-03 |  | SIT | 54.33 | Green | Roger Robar | 6.0 | GREEN |  |  |  |  |  |
| 1526 | 1.4.2.3.3.2.4.8 | Sprint 11 |  | 10d | 2025-02-03 | 2025-02-14 | 1525 |  |  |  |  | 2025-02-03 | 2025-02-14 | 0d |  |  | 5d | 0d | finish no earlier than 2025-01-17 |  | SIT | 68.33 | Green | Roger Robar | 6.0 | GREEN |  |  |  |  |  |
| 1527 | 1.4.2.3.3.2.4.9 | Sprint 12 |  | 10d | 2025-02-17 | 2025-02-28 | 1526 |  |  |  |  | 2025-02-17 | 2025-02-28 | 0d |  |  | 5d | 0d | finish no earlier than 2025-01-31 |  | SIT | 82.33 | Green | Roger Robar | 6.0 | GREEN |  |  |  |  |  |
| 1528 | 1.4.2.3.3.2.4.10 | Sprint 13 |  | 10d | 2025-03-03 | 2025-03-14 | 1527 |  |  |  |  | 2025-03-03 | 2025-03-14 | 0d |  |  | 5d | 0d |  |  | SIT | 96.33 | Green | Roger Robar | 6.1 | GREEN |  |  |  |  |  |
| 1529 | 1.4.2.3.3.2.4.11 | Sprint 14 (RTTM Gap Analysis + CR056) |  | 10d? | 2025-03-17 | 2025-03-28 | 1528 |  |  |  |  | 2025-03-17 | 2025-03-28 | 0d |  |  | 5d | 0d |  |  | SIT | 110.33 | Green | Roger Robar | 6.1 | GREEN |  |  |  |  |  |
| 1530 | 1.4.2.3.3.2.4.12 | Sprint 15 (Contingency 1) |  | 10d? | 2025-03-31 | 2025-04-11 | 1529 |  |  |  |  | 2025-03-31 | 2025-04-11 | 0d |  |  | 5d | 0d |  |  | SIT | 124.33 | Green | Roger Robar | 6.1 | GREEN |  |  |  |  |  |
| 1531 | 1.4.2.3.3.2.4.13 | Sprint 16 (Contingency 2) |  | 10d? | 2025-04-14 | 2025-04-25 | 1530 |  |  |  |  | 2025-04-14 | 2025-04-25 | 0d |  |  | 5d | 0d |  |  | SIT | 138.33 | Green | Roger Robar | 6.1 | GREEN |  |  |  |  |  |
| 1532 | 1.4.2.3.3.2.4.14 | SIT Migration Cycle 3 Complete |  | 1d? | 2022-10-31 | 2022-10-31 |  |  |  |  |  |  |  |  |  |  | 1343d |  |  |  |  | -757.67 | Overdue Start |  | 6.1 | RED |  |  |  |  | T2-TE-1200 |

Notes:
- 1516: 13/11/24 - 8/9 prerequisite test complete, final test relies on deployment of IR8.4.
- 1532: 25/11/24 - New milestone added by Programme, awaiting formal SITAG approval. Programme will also be adding in dependencies.

| ID | WBS | Task | Type | Duration | Start | Finish | Predecessors | Baseline start | Baseline finish | Baseline duration | Baseline 1 start | Baseline 1 finish | Total slack | Free slack | Constraint | Text9 | Task Status | Update Version | Sched Status | MHHS Resource Name | RAG | Responsible | Involved | Artefact ID | MHHS Programme Phase | Milestone ID | Text29 | Tier | Future RAG | Guidance |
| --- | --- | --- | --- | --- | --- | --- | --- | --- | --- | --- | --- | --- | --- | --- | --- | --- | --- | --- | --- | --- | --- | --- | --- | --- | --- | --- | --- | --- | --- | --- |
| 1533 | 1.4.2.3.3.2.5 | **SIT Migration MVC Regression Testing (code freeze)** |  | 35d? | 2025-06-16 | 2025-08-01 |  | 2025-06-16 | 2025-08-01 | 0d |  |  | 609d |  |  | SIT | -685.67 | 6.0 | Overdue Start | Roger Robar |  |  |  |  |  |  |  |  |  |  |
| 1534 | 1.4.2.3.3.2.5.1 | Regression Sprint 1 |  | 10d? | 2025-06-16 | 2025-06-27 | 1489 | 2025-06-16 | 2025-06-27 | 0d |  |  | 609d | 0d |  | SIT | 201.33 | 6.0 | Green | Roger Robar | GREEN |  |  |  |  |  |  |  |  |  |
| 1535 | 1.4.2.3.3.2.5.2 | Regression Sprint 2 |  | 10d? | 2025-06-30 | 2025-07-11 | 1534 | 2025-06-30 | 2025-07-11 | 0d |  |  | 609d | 0d |  | SIT | 215.33 | 6.0 | Green | Roger Robar | GREEN |  |  |  |  |  |  |  |  |  |
| 1536 | 1.4.2.3.3.2.5.3 | Regression Sprint 3 |  | 15d? | 2025-07-14 | 2025-08-01 | 1535 | 2025-07-14 | 2025-08-01 | 0d |  |  | 609d | 0d |  | SIT | 229.33 | 6.0 | Green | Roger Robar | GREEN |  |  |  |  |  |  |  |  |  |
| 1537 | 1.4.2.3.3.2.5.4 | SIT Migration Testing End (Minimum Viable Cohort) (incl. confirmation that PPs have submitted their Test Completion Reports to Programme for assurance) | milestone | 0d | 2025-08-01 | 2025-08-01 | 1536 | 2025-08-01 | 2025-08-01 | 0d |  |  | 609d | 0d | start no earlier than 2025-06-20 | SIT | 247.71 | 6.0 | Green | Roger Robar | GREEN |  |  |  |  |  |  |  |  |  |
| 1538 | 1.4.2.3.3.2.6 | **SIT Migration Test Completion Report (Minimum Viable Cohort)** |  | 25d | 2025-07-14 | 2025-08-15 | 1060, 964, 968, 975, 981, 987 | 2025-07-14 | 2025-08-15 | 0d | 2024-06-10 | 2024-06-10 | 609d |  |  | SIT |  | 6.1 | Complete |  |  | SI Test | PP | MHHS-ART076 | Systems Integration Testing (SIT) | T3-TE-0038 | SITAG | T3 |  |  |
| 1539 | 1.4.2.3.3.2.6.1 | Develop document |  | 15d | 2025-07-14 | 2025-08-01 | 1537FF | 2025-07-14 | 2025-08-01 | 85d | 2024-06-10 | 2024-10-04 | 609d | 0d |  | SIT | 229.33 | 6.1 | Green | Roger Robar | GREEN | SI Test | PP |  | Systems Integration Testing (SIT) |  |  |  | D24E - Migration Test Completion Report |  |
| 1540 | 1.4.2.3.3.2.6.2 | Review & agree document |  | 5d | 2025-08-04 | 2025-08-08 | 1539 | 2025-08-04 | 2025-08-08 | 10d | 2024-10-21 | 2024-11-01 | 609d | 0d |  | SIT | 250.33 | 6.1 | Green | Roger Robar | GREEN | SI Test | PP |  | Systems Integration Testing (SIT) |  |  |  |  |  |
| 1541 | 1.4.2.3.3.2.6.3 | SIT Migration Testing Test Completion Report (Minimum Viable Cohort) Approved | milestone | 0d | 2025-08-15 | 2025-08-15 | 1540FS+5d | 2025-08-15 | 2025-08-15 | 45d |  |  | 609d | 0d |  | SIT | 261.71 | 6.1 | Green |  | GREEN | SI Test |  |  |  | T2-TE-0800 | SITAG |  |  |  |
| 1542 | 1.4.2.3.3.2.7 | SIT Migration Testing End (Minimum Viable Cohort) (incl. confirmation that PPs have submitted their Test Completion Reports to Programme for assurance) | milestone | 0d | 2025-08-15 | 2025-08-15 | 1539FF, 1541 | 2025-08-15 | 2025-08-15 | 0d | 2024-10-04 | 2024-10-04 | 609d | 0d | start no earlier than 2025-03-14 | SIT | 261.71 | 6.1 | Green | Roger Robar | GREEN | SI Test | PP | MHHS-ART076 | Systems Integration Testing (SIT) | T3-TE-0043 | SITAG | T3 |  |  |
| 1543 | 1.4.2.3.3.2.8 | Assurance of PPs Test Completion Reports |  | 30d | 2025-07-14 | 2025-08-22 | 1542FF+5d | 2025-07-14 | 2025-08-22 | 30d | 2024-09-02 | 2024-10-11 | 609d |  |  | SIT | 229.33 | 6.1 | Green | Roger Robar | GREEN | SI Test | PP |  | Systems Integration Testing (SIT) |  |  |  |  |  |
| 1544 | 1.4.2.3.4 | **SIT Non-Functional Testing (all SIT PPs)** |  | 104d? | 2025-01-13 | 2025-06-05 |  | 2025-01-13 | 2025-06-05 | 100d | 2024-09-02 | 2025-01-17 | 61d |  |  | SIT |  | 6.1 |  | N/A |  | N/A | N/A |  | Systems Integration Testing (SIT) |  | SITAG |  |  |  |
| 1545 | 1.4.2.3.4.1 | Theme 1 (Helix and DIP Volume Testing) Start | milestone | 0d? | 2025-01-13 | 2025-01-13 | 1138 | 2025-01-13 | 2025-01-13 | 0d |  |  | 61d | 0d | start no earlier than 2025-01-13 | SIT | 47.33 | 6.0 | Green | Roger Robar | GREEN | SIT Participant |  |  |  | T3-TE-0124 | SITAG |  |  |  |
| 1546 | 1.4.2.3.4.2 | Theme 1 (Helix and DIP Volume Testing) Execution |  | 15d? | 2025-01-13 | 2025-01-31 | 1545 | 2025-01-13 | 2025-01-31 | 0d |  |  | 61d | 0d | start no earlier than 2025-01-13 | SIT | 47.33 | 6.1 | Green | Roger Robar | GREEN |  |  |  |  |  |  |  |  |  |
| 1547 | 1.4.2.3.4.3 | Theme 2 SIT Non-Functional Testing Start | milestone | 0d | 2025-03-14 | 2025-03-14 | 1156FS+5d, 1456FS+5d, 1067, 1071, 1078, 1084, 1090, 1140, 1144, 1488 | 2025-03-17 | 2025-03-17 | 0d | 2024-09-02 | 2024-09-02 | 111d | 0d |  | SIT | 107.71 | 6.13 | Green | Roger Robar | GREEN | SI Test | PP | MHHS-ART079 | Systems Integration Testing (SIT) | T3-TE-0040 | SITAG | T3 |  | 12/8/24: needs to be 7/10/24 |
| 1548 | 1.4.2.3.4.4 | Theme 2 SIT Non-Functional Testing Execution |  | 40d | 2025-03-14 | 2025-05-08 | 1547SS-1d | 2025-03-17 | 2025-05-09 | 90d | 2024-09-02 | 2025-01-03 | 72d | 10d |  | SIT | 107.33 | 6.13 | Green | Roger Robar | GREEN | SI Test | PP |  | Systems Integration Testing (SIT) |  |  |  | D24D - NF Test Completion Report |  |
| 1549 | 1.4.2.3.4.5 | Theme 3 SIT Non-Functional Testing Start |  | 1d? | 2025-03-17 | 2025-03-17 | 1140, 1144 | 2025-03-17 | 2025-03-17 | 0d |  |  | 71d | 0d |  | SIT | 110.33 | 6.1 | Green | Roger Robar | GREEN |  |  |  |  |  |  |  |  |  |
| 1550 | 1.4.2.3.4.6 | Theme 3 SIT Non-Functional Testing Execution |  | 40d? | 2025-03-17 | 2025-05-09 | 1549SS | 2025-03-17 | 2025-05-09 | 0d |  |  | 71d | 9d |  | SIT | 110.33 | 6.1 | Green | Roger Robar | GREEN |  |  |  |  |  |  |  |  |  |
| 1551 | 1.4.2.3.4.7 | SIT Non-Functional Testing End (all SIT PPs) (incl. confirmation that PPs have submitted their Test Completion Reports to Programme for assurance) | milestone | 0d | 2025-05-23 | 2025-05-23 | 1548FF, 1550FF | 2025-05-23 | 2025-05-23 | 0d | 2025-01-03 | 2025-01-03 | 62d | 0d | start no earlier than 2025-05-23 | SIT | 177.33 | 6.1 | Green | Roger Robar | GREEN | SI Test | PP | MHHS-ART079 | Systems Integration Testing (SIT) | T3-TE-0047 | SITAG | T3 |  |  |
| 1552 | 1.4.2.3.4.8 | Assurance of PPs Test Completion Reports |  | 20d | 2025-05-02 | 2025-05-29 | 1551FF+5d | 2025-05-02 | 2025-05-29 | 30d | 2024-12-02 | 2025-01-10 | 62d | 0d |  | SIT | 156.33 | 6.1 | Green | Roger Robar | GREEN | SI Test | PP |  | Systems Integration Testing (SIT) |  |  |  |  |  |
| 1553 | 1.4.2.3.4.9 | **SIT Non-Functional Testing Test Completion Report (all SIT PPs)** |  | 20d | 2025-05-02 | 2025-05-29 |  | 2025-05-02 | 2025-05-29 | 20d | 2024-12-16 | 2025-01-10 | 62d |  |  | SIT |  | 6.1 |  | N/A |  | N/A | N/A |  | Systems Integration Testing (SIT) |  |  |  |  |  |
| 1554 | 1.4.2.3.4.9.1 | Develop document |  | 15d | 2025-05-02 | 2025-05-23 | 1551FF | 2025-05-02 | 2025-05-23 | 15d | 2024-12-16 | 2025-01-03 | 62d | 0d |  | SIT | 156.33 | 6.1 | Green | Roger Robar | GREEN | SI Test |  |  | Systems Integration Testing (SIT) |  |  |  |  |  |
| 1555 | 1.4.2.3.4.9.2 | Review & agree document |  | 5d | 2025-05-23 | 2025-05-29 | 1554, 1552FF | 2025-05-23 | 2025-05-29 | 5d | 2025-01-06 | 2025-01-10 | 62d | 0d |  | SIT | 177.33 | 6.1 | Green | Roger Robar | GREEN | SI Test | PP,IPA |  | Systems Integration Testing (SIT) |  |  |  |  |  |
| 1556 | 1.4.2.3.4.10 | SIT Non-Functional Testing Test Completion Report (all SIT PPs) Approved | milestone | 0d | 2025-06-05 | 2025-06-05 | 1555FF+5d | 2025-06-05 | 2025-06-05 | 0d | 2025-01-17 | 2025-01-17 | 62d | 56d |  | SIT | 190.71 | 6.1 | Green | Roger Robar | GREEN | SI Test | PP | MHHS-ART079 | Systems Integration Testing (SIT) | T2-TE-0900 | SITAG | T2 |  |  |

Notes:
- 1542: 16/09/24 - Date pushed back to 14/03/25, in line with recalibration exercise.
- 1547: 21/11/24 - Date corrected by pushing back one day.
- 1548: 21/11/24 - Date corrected by pushing back one day.
- 1551: 16/09/24 - Date pushed back to 23/05/25, in line with recalibration exercise.
- 1556: 06/08/24: Date at risk due to lower than expected test velocity. Start of SIT-Non Functional (MVC) could be delayed.

| ID | WBS | Task | Type | Duration | Start | Finish | Predecessors | Complete | Remaining | Baseline start | Baseline finish | Baseline duration | Baseline 1 start | Baseline 1 finish | Total slack | Free slack | Constraint | Baseline cost | Responsible | Involved | Text9 | Update Version | MHHS Resource Name | MHHS Programme Phase | Text29 | Task Status | Sched Status | RAG | Milestone ID | Artefact ID | Tier | Future RAG |
| --- | --- | --- | --- | --- | --- | --- | --- | --- | --- | --- | --- | --- | --- | --- | --- | --- | --- | --- | --- | --- | --- | --- | --- | --- | --- | --- | --- | --- | --- | --- | --- | --- |
| 1557 | 1.4.2.3.5 | **SIT Operational Testing (all SIT PPs)** |  | 90d? | 2025-02-03 | 2025-06-06 |  |  |  | 2025-02-03 | 2025-06-06 | 90d | 2024-10-07 | 2025-02-07 | 61d |  |  |  | N/A | N/A | SIT | 5.0 | N/A | Systems Integration Testing (SIT) | SITAG |  |  |  |  |  |  |  |
| 1558 | 1.4.2.3.5.1 | **Non-SIT B Testing** |  | 25d? | 2025-02-03 | 2025-03-07 |  |  |  | 2025-02-03 | 2025-03-07 | 0d |  |  | 116d |  |  |  |  |  | SIT |  |  |  | SITAG | -686.67 | Overdue Start |  |  |  |  |  |
| 1559 | 1.4.2.3.5.1.1 | SIT Operational Testing Start (Theme 3 - Batch 1 (Service Management)) | milestone | 0d? | 2025-02-03 | 2025-02-03 | 1302, 1241, 1242 |  |  | 2025-02-03 | 2025-02-03 | 0d |  |  | 116d | 0d | start no earlier than 2025-02-03 |  | SI Test |  | SIT | 6.0 |  |  | SITAG | 68.33 | Green | GREEN | T3-TE-0121 |  |  |  |
| 1560 | 1.4.2.3.5.1.2 | SIT Operational Testing Execution Window (Theme 3 - Batch 1 (Service Management)) |  | 25d? | 2025-02-03 | 2025-03-07 | 1559 |  |  | 2025-02-03 | 2025-03-07 | 0d |  |  | 116d | 55d | start no earlier than 2025-01-06 |  |  |  | SIT | 6.0 |  |  |  | 68.33 | Green | GREEN |  |  |  |  |
| 1561 | 1.4.2.3.5.2 | **SIT B Testing** |  | 70d? | 2025-02-07 | 2025-05-16 |  |  |  | 2025-02-07 | 2025-05-16 | 0d |  |  | 61d |  |  |  |  |  | SIT | 6.0 |  |  |  | -686.67 | Overdue Start |  |  |  |  |  |
| 1562 | 1.4.2.3.5.2.1 | SIT Operational Testing Start (SIT B) | milestone | 0d | 2025-02-07 | 2025-02-07 | 1349FS+8d, 1164, 1168, 1175, 1181, 1302, 1141, 1142 |  |  | 2025-02-07 | 2025-02-07 | 0d | 2024-10-07 | 2024-10-07 | 61d | 0d |  |  | SI Test | PP | SIT | 6.0 | Roger Robar | Systems Integration Testing (SIT) | SITAG | 72.71 | Green | GREEN | T3-TE-0042 | MHHS-ART073 MHHS-ART143 | T3 |  |
| 1563 | 1.4.2.3.5.2.2 | SIT Operational Testing Execution Theme 3 Batch 2 |  | 25d? | 2025-02-10 | 2025-03-14 | 1562, 1288 |  |  | 2025-02-10 | 2025-03-14 | 0d |  |  | 61d | 0d |  |  |  |  | SIT | 6.0 |  |  |  | 75.33 | Green | GREEN |  |  |  |  |
| 1564 | 1.4.2.3.5.2.3 | SIT Operational Testing Execution Theme 1 |  | 25d? | 2025-03-17 | 2025-04-18 | 1563 |  |  | 2025-03-17 | 2025-04-18 | 0d |  |  | 61d | 0d |  |  |  |  | SIT | 6.0 |  |  |  | 110.33 | Green | GREEN |  |  |  |  |
| 1565 | 1.4.2.3.5.2.4 | SIT Operational Testing Execution Theme 2 |  | 20d? | 2025-04-21 | 2025-05-16 | 1564 |  |  | 2025-04-21 | 2025-05-16 | 0d |  |  | 61d | 0d |  |  |  |  | SIT | 6.0 |  |  |  | 145.33 | Green | GREEN |  |  |  |  |
| 1566 | 1.4.2.3.5.3 | SIT Operational Testing End (all SIT PPs) (incl. confirmation that PPs have submitted their Test Completion Reports to Programme for assurance) | milestone | 0d | 2025-05-23 | 2025-05-23 | 1565FS+5d, 1560 |  |  | 2025-05-23 | 2025-05-23 | 0d | 2025-01-24 | 2025-01-24 | 61d | 0d |  |  | SI Test | PP | SIT | 6.0 | Roger Robar | Systems Integration Testing (SIT) | SITAG | 177.71 | Green | GREEN | T3-TE-0050 | MHHS-ART081 | T3 |  |
| 1567 | 1.4.2.3.5.4 | Assurance of PPs Test Completion Reports |  | 30d | 2025-04-21 | 2025-05-30 | 1566FF+5d |  |  | 2025-04-21 | 2025-05-30 | 30d | 2024-12-23 | 2025-01-31 | 61d | 0d |  |  | SI Test | PP | SIT | 6.0 | Roger Robar | Systems Integration Testing (SIT) |  | 145.33 | Green | GREEN |  |  |  |  |
| 1568 | 1.4.2.3.5.5 | **SIT Operational Testing Test Completion Report (all SIT PPs)** |  | 20d | 2025-05-05 | 2025-05-30 |  |  |  | 2025-05-05 | 2025-05-30 | 20d | 2025-01-06 | 2025-01-31 | 61d |  |  |  | N/A | N/A | SIT | 6.0 | N/A | Systems Integration Testing (SIT) |  |  |  |  |  |  |  |  |
| 1569 | 1.4.2.3.5.5.1 | Develop document |  | 15d | 2025-05-05 | 2025-05-23 | 1566FF |  |  | 2025-05-05 | 2025-05-23 | 15d | 2025-01-06 | 2025-01-24 | 61d | 0d |  |  | SI Test |  | SIT | 6.0 | Roger Robar | Systems Integration Testing (SIT) |  | 159.33 | Green | GREEN |  |  |  |  |
| 1570 | 1.4.2.3.5.5.2 | Review & agree document |  | 5d | 2025-05-26 | 2025-05-30 | 1569, 1567FF |  |  | 2025-05-26 | 2025-05-30 | 5d | 2025-01-27 | 2025-01-31 | 61d | 0d |  |  | SI Test | PP,IPA | SIT | 6.0 | Roger Robar | Systems Integration Testing (SIT) |  | 180.33 | Green | GREEN |  |  |  |  |
| 1571 | 1.4.2.3.5.6 | SIT Operational Testing Test Completion Report (all SIT PPs) Approved | milestone | 0d | 2025-06-06 | 2025-06-06 | 1570FF+5d |  |  | 2025-06-06 | 2025-06-06 | 0d | 2025-02-07 | 2025-02-07 | 61d | 55d |  |  | SI Test | PP | SIT | 6.0 | Roger Robar | Systems Integration Testing (SIT) | SITAG | 191.71 | Green | GREEN | T2-TE-0950 | MHHS-ART081 | T2 |  |
| 1572 | 1.4.2.3.6 | **SIT MVC Test Exit Report** |  | 20d | 2025-07-14 | 2025-08-08 |  |  |  | 2025-07-14 | 2025-08-08 | 20d | 2025-01-06 | 2025-01-31 | 619d |  |  |  | N/A | N/A | SIT | 6.0 | N/A | Systems Integration Testing (SIT) |  |  |  |  |  |  |  |  |
| 1573 | 1.4.2.3.6.1 | Develop document |  | 15d | 2025-07-14 | 2025-08-01 | 1498FF |  |  | 2025-07-14 | 2025-08-01 | 15d | 2025-01-06 | 2025-01-24 | 619d | 0d |  |  | SI Test |  | SIT | 6.0 | Roger Robar | Systems Integration Testing (SIT) |  | 229.33 | Green | GREEN |  |  |  |  |
| 1574 | 1.4.2.3.6.2 | Review & agree document |  | 5d | 2025-08-04 | 2025-08-08 | 1573 |  |  | 2025-08-04 | 2025-08-08 | 5d | 2025-01-27 | 2025-01-31 | 619d |  |  |  | SI Test | PP,IPA | SIT | 6.0 | Roger Robar | Systems Integration Testing (SIT) |  | 250.33 | Green | GREEN |  |  |  |  |
| 1575 | 1.4.2.3.7 | SIT Minimum Viable Cohort Complete (SIT Minimum Viable Cohort Test Exit Report Approved) | milestone | 0d | 2025-08-22 | 2025-08-22 | 1447, 1500FS+5d, 1556, 1571 |  |  | 2025-08-22 | 2025-08-22 | 0d | 2025-02-07 | 2025-02-07 | 6d | 0d |  |  | CPT | PP,IPA | SIT | 6.0 | Roger Robar | Systems Integration Testing (SIT) | PSG | 268.71 | Green | GREEN | T1-TE-2000 | MHHS-ART081 | T1 |  |
| 1576 | 1.4.2.4 | **SIT (non-MVC)** |  | 119d? | 2025-06-16 A | 2025-11-27 |  | 10% | 106.64d? | 2025-05-05 | 2025-11-27 | 295d | 2024-03-11 | 2025-04-25 | 29d |  |  | -0 | N/A | N/A | SIT | 6.0 | N/A | Systems Integration Testing (SIT) |  | M10,M11 |  |  |  |  |  | D24D - NF Test Completion Report |
| 1577 | 1.4.2.4.1 | **SIT Functional Testing (non-MVC)** |  | 110d? | 2025-06-16 | 2025-11-14 |  |  |  | 2025-06-16 | 2025-11-14 | 295d | 2024-03-11 | 2025-04-25 | 29d |  |  |  | N/A | N/A | SIT | 6.0 | N/A | Systems Integration Testing (SIT) |  |  |  |  |  |  |  |  |
| 1578 | 1.4.2.4.1.1 | **SIT Functional Testing Execution (non-MVC)** |  | 95d? | 2025-06-16 | 2025-10-24 |  |  |  | 2025-06-16 | 2025-10-24 | 280d | 2024-03-11 | 2025-04-04 | 29d |  |  |  | N/A | N/A | SIT | 6.0 | N/A | Systems Integration Testing (SIT) |  | M10 |  |  |  |  |  | D24C - E2E Test Completion Report |
| 1579 | 1.4.2.4.1.1.1 | Test Execution (Cycle 3 Completion and Regression Testing) |  | 95d? | 2025-06-16 | 2025-10-24 | 1489 |  |  | 2025-06-16 | 2025-10-24 | 0d |  |  | 29d | 0d |  |  |  |  | SIT | 6.0 |  |  |  | 201.33 | Green | GREEN |  |  |  |  |
| 1580 | 1.4.2.4.1.1.2 | SIT Functional Testing End (non-MVC) (incl. confirmation that PPs have submitted their Test Completion Reports to Programme for assurance) | milestone | 0d | 2025-10-24 | 2025-10-24 | 1579FF |  |  | 2025-10-24 | 2025-10-24 | 0d | 2025-04-04 | 2025-04-04 | 29d | 0d |  |  | SI Test | PP | SIT | 6.0 | Roger Robar | Systems Integration Testing (SIT) | SITAG | 331.71 | Green | GREEN | T3-TE-0052 | MHHS-ART072 | T3 |  |
| 1581 | 1.4.2.4.1.2 | Assurance of PPs Test Completion Reports |  | 5d | 2025-11-03 | 2025-11-07 | 1580FS+5d |  |  | 2025-11-03 | 2025-11-07 | 5d | 2025-04-14 | 2025-04-18 | 29d | 0d |  |  | SI Test | PP | SIT | 6.0 | Roger Robar | Systems Integration Testing (SIT) |  | 341.33 | Green | GREEN |  |  |  |  |

| ID | WBS | Task | Type | Duration | Start | Finish | Predecessors | Complete | Remaining | Baseline start | Baseline finish | Baseline duration | Baseline 1 start | Baseline 1 finish | Total slack | Free slack | Constraint | Baseline cost | Responsible | Involved | Text9 | Update Version | MHHS Resource Name | MHHS Programme Phase | Task Status | Sched Status | RAG | Artefact ID | Milestone ID | Text29 | Tier | Future RAG |
| --- | --- | --- | --- | --- | --- | --- | --- | --- | --- | --- | --- | --- | --- | --- | --- | --- | --- | --- | --- | --- | --- | --- | --- | --- | --- | --- | --- | --- | --- | --- | --- | --- |
| 1582 | 1.4.2.4.1.3 | **SIT Functional Testing Test Completion Report (non-MVC)** |  | 25d | 2025-10-06 | 2025-11-07 |  |  |  | 2025-10-06 | 2025-11-07 | 25d | 2025-03-17 | 2025-04-18 | 29d |  |  |  | N/A | N/A | SIT | 6.0 | N/A | Systems Integration Testing (SIT) |  |  |  |  |  |  |  |  |
| 1583 | 1.4.2.4.1.3.1 | Develop document |  | 15d | 2025-10-06 | 2025-10-24 | 1580FF |  |  | 2025-10-06 | 2025-10-24 | 15d | 2025-03-17 | 2025-04-04 | 34d | 5d |  |  | SI Test |  | SIT | 6.0 | Roger Robar | Systems Integration Testing (SIT) | 313.33 | Green | GREEN |  |  |  |  |  |
| 1584 | 1.4.2.4.1.3.2 | Review & agree document |  | 5d | 2025-11-03 | 2025-11-07 | 1583, 1581FF |  |  | 2025-11-03 | 2025-11-07 | 5d | 2025-04-14 | 2025-04-18 | 29d | 0d |  |  | SI Test | PP,IPA | SIT | 6.0 | Roger Robar | Systems Integration Testing (SIT) | 341.33 | Green | GREEN |  |  |  |  |  |
| 1585 | 1.4.2.4.1.4 | SIT Functional Testing Test Completion Report (non-MVC) Approved | milestone | 0d | 2025-11-14 | 2025-11-14 | 1584FF+5d |  |  | 2025-11-14 | 2025-11-14 | 0d | 2025-04-25 | 2025-04-25 | 29d | 0d |  |  | SI Test | PP | SIT | 6.0 | Roger Robar | Systems Integration Testing (SIT) | 352.71 | Green | GREEN | MHHS-ART072 | T3-TE-0055 | SITAG | T3 |  |
| 1586 | 1.4.2.4.2 | **SIT Migration Testing (non-MVC)** |  | 110d | 2025-06-16 A | 2025-11-14 |  | 23% | 85.25d | 2025-05-05 | 2025-10-08 | 230d | 2024-06-10 | 2025-04-25 | 29d |  |  |  | N/A | N/A | SIT | 6.0 | N/A | Systems Integration Testing (SIT) |  |  |  |  |  |  |  |  |
| 1587 | 1.4.2.4.2.1 | Test Execution (Cycle 3 Completion and Regression Testing) |  | 95d | 2025-06-16 A | 2025-10-24 | 1489 | 28% | 68d | 2025-06-16 | 2025-10-24 | 215d | 2024-06-10 | 2025-04-04 | 29d | 0d |  |  | SI Test | PP | SIT | 6.0 | Roger Robar | Systems Integration Testing (SIT) |  | Green | GREEN |  |  |  |  | D24E - Migration Test Completion Report |
| 1588 | 1.4.2.4.2.2 | SIT Migration Testing End (non-MVC) (incl. confirmation that PPs have submitted their Test Completion Reports to Programme for assurance) | milestone | 0d | 2025-10-24 | 2025-10-24 | 1587FF |  |  | 2025-10-24 | 2025-10-24 | 0d | 2025-04-04 | 2025-04-04 | 29d | 0d |  |  | SI Test | PP | SIT | 6.0 | Roger Robar | Systems Integration Testing (SIT) | 331.71 | Green | GREEN | MHHS-ART076 | T3-TE-0051 | SITAG | T3 |  |
| 1589 | 1.4.2.4.2.3 | Assurance of PPs Test Completion Reports |  | 5d | 2025-11-03 | 2025-11-07 | 1588FS+5d |  |  | 2025-11-03 | 2025-11-07 | 5d | 2025-04-14 | 2025-04-18 | 29d | 0d |  |  | SI Test | PP | SIT | 6.0 | Roger Robar | Systems Integration Testing (SIT) | 341.33 | Green | GREEN |  |  |  |  |  |
| 1590 | 1.4.2.4.2.4 | **SIT Migration Testing Test Completion Report (non-MVC)** |  | 25d | 2025-10-06 | 2025-11-07 |  |  |  | 2025-10-06 | 2025-11-07 | 25d | 2025-03-17 | 2025-04-18 | 29d |  |  |  | N/A | N/A | SIT | 6.0 | N/A | Systems Integration Testing (SIT) |  |  |  |  |  |  |  |  |
| 1591 | 1.4.2.4.2.4.1 | Develop document |  | 15d | 2025-10-06 | 2025-10-24 | 1588FF |  |  | 2025-10-06 | 2025-10-24 | 15d | 2025-03-17 | 2025-04-04 | 34d | 5d |  |  | SI Test |  | SIT | 6.0 | Roger Robar | Systems Integration Testing (SIT) | 313.33 | Green | GREEN |  |  |  |  |  |
| 1592 | 1.4.2.4.2.4.2 | Review & agree document |  | 5d | 2025-11-03 | 2025-11-07 | 1591, 1589FF |  |  | 2025-11-03 | 2025-11-07 | 5d | 2025-04-14 | 2025-04-18 | 29d | 0d |  |  | SI Test | PP,IPA | SIT | 6.0 | Roger Robar | Systems Integration Testing (SIT) | 341.33 | Green | GREEN |  |  |  |  |  |
| 1593 | 1.4.2.4.2.5 | SIT Migration Testing Test Completion Report (non-MVC Approved) | milestone | 0d | 2025-11-14 | 2025-11-14 | 1592FF+5d |  |  | 2025-11-14 | 2025-11-14 | 0d | 2025-04-25 | 2025-04-25 | 29d | 0d |  |  | SI Test | PP | SIT | 6.0 | Roger Robar | Systems Integration Testing (SIT) | 352.71 | Green | GREEN | MHHS-ART076 | T3-TE-0056 | SITAG | T3 |  |
| 1594 | 1.4.2.4.3 | **SIT non-MVC Test Exit Report** |  | 20d | 2025-10-27 | 2025-11-21 |  |  |  | 2025-10-27 | 2025-11-21 | 20d | 2025-03-17 | 2025-04-11 | 29d |  |  |  | N/A | N/A | SIT | 6.0 | N/A | Systems Integration Testing (SIT) |  |  |  |  |  |  |  |  |
| 1595 | 1.4.2.4.3.1 | Develop document |  | 15d | 2025-10-27 | 2025-11-14 | 1585FF, 1593FF |  |  | 2025-10-27 | 2025-11-14 | 15d | 2025-03-17 | 2025-04-04 | 29d | 0d |  |  | SI Test |  | SIT | 6.0 | Roger Robar | Systems Integration Testing (SIT) | 334.33 | Green | GREEN |  |  |  |  |  |
| 1596 | 1.4.2.4.3.2 | Review & agree document |  | 5d | 2025-11-17 | 2025-11-21 | 1595 |  |  | 2025-11-17 | 2025-11-21 | 5d | 2025-04-07 | 2025-04-11 | 29d | 0d |  |  | SI Test | PP,IPA | SIT | 6.0 | Roger Robar | Systems Integration Testing (SIT) | 355.33 | Green | GREEN |  |  |  |  |  |
| 1597 | 1.4.2.4.4 | SIT non-MVC Complete | milestone | 0d | 2025-11-27 | 2025-11-27 | 1596FS+4d, 1585, 1593 |  |  | 2025-11-27 | 2025-11-27 | 0d | 2025-04-21 | 2025-04-21 | 29d | 0d |  |  | SI Test | PP | SIT | 6.0 | Roger Robar | Systems Integration Testing (SIT) | 365.71 | Green | GREEN | MHHS-ART081 | T3-TE-0059 | SITAG | T3 |  |
| 1598 | 1.4.3 | **UIT Environment Preparation** |  | 700d? | 2022-10-31 A | 2025-07-04 |  | 48% | 365.49d? | 2022-10-31 | 2025-07-04 | 680d | 2022-10-31 | 2025-06-06 | 644d |  |  | -0 | N/A | N/A | SIT | 6.0 | N/A | Systems Integration Testing (SIT) |  |  |  |  |  | SITAG |  |  |
| 1599 | 1.4.3.1 | **Test Artefact Development** |  | 556d? | 2023-03-01 A | 2025-04-16 |  | 51% | 270.06d? | 2023-03-01 | 2024-07-18 | 361d | 2023-03-01 | 2023-08-04 | 701d |  |  | -0 | N/A | N/A | SIT | 6.0 | N/A | Systems Integration Testing (SIT) |  |  |  |  |  | SITAG |  |  |
| 1600 | 1.4.3.1.1 | **E2E Sandbox Guidance** |  | 539d? | 2023-03-01 A | 2025-03-24 |  | 71% | 158.53d? | 2023-03-01 | 2024-07-18 | 361d | 2023-03-01 | 2023-08-04 | 718d |  |  | -0 | N/A | N/A | SIT | 6.0 | N/A | Systems Integration Testing (SIT) |  |  |  |  |  |  |  |  |
| 1601 | 1.4.3.1.1.1 | Develop document |  | 83d | 2023-03-01 A | 2023-06-23 A |  | 100% |  | 2023-03-01 | 2023-06-23 | 83d | 2023-03-01 | 2023-06-23 |  |  | start no earlier than 2023-03-01 |  | SI Test |  | SIT | 6.0 | Stuart Scott | Systems Integration Testing (SIT) |  | Complete | COMPLETE |  |  |  |  |  |
| 1602 | 1.4.3.1.1.2 | Artefact review (via SITAG) and updates |  | 25d | 2023-06-26 A | 2023-07-28 A | 1601 | 100% |  | 2023-06-26 | 2023-07-28 | 25d | 2023-06-26 | 2023-07-28 |  |  |  |  | SI Test | PP,IPA | SIT | 6.0 | Stuart Scott | Systems Integration Testing (SIT) |  | Complete | COMPLETE |  |  |  |  |  |
| 1603 | 1.4.3.1.1.3 | E2E Sandbox Guidance approved | milestone | 0d | 2024-07-18 A | 2024-07-18 A | 1602FF+5d | 100% |  | 2024-07-18 | 2024-07-18 | 0d | 2023-08-04 | 2023-08-04 |  |  | start no earlier than 2024-07-18 |  | SI Test | PP | SIT | 6.0 | Stuart Scott | Systems Integration Testing (SIT) |  | Complete | COMPLETE | MHHS-ART154 | T3-TE-0067 | QAG | T3 |  |
| 1604 | 1.4.3.1.1.4 | Update E2E Sandbox guidance to reflect CR55 |  | 29d | 2025-01-13 | 2025-02-20 |  |  |  | 2025-01-13 | 2025-02-20 | 0d |  |  | 718d | 0d | start no earlier than 2025-01-13 |  |  |  | SIT | 6.1 | Stuart Scott |  | 47.33 | Green | GREEN |  |  |  |  |  |
| 1605 | 1.4.3.1.1.5 | Internal SI review |  | 5d | 2025-02-21 | 2025-02-27 | 1604 |  |  | 2025-02-21 | 2025-02-27 | 0d |  |  | 718d | 0d |  |  |  |  | SIT | 6.1 | Stuart Scott |  | 86.33 | Green | GREEN |  |  |  |  |  |
| 1606 | 1.4.3.1.1.6 | SRO / Code Bodies review |  | 5d | 2025-02-28 | 2025-03-06 | 1605 |  |  | 2025-02-28 | 2025-03-06 | 0d |  |  | 718d | 0d |  |  |  |  | SIT | 6.1 | Stuart Scott |  | 93.33 | Green | GREEN |  |  |  |  |  |
| 1607 | 1.4.3.1.1.7 | Submit version to QWG |  | 3d | 2025-03-07 | 2025-03-11 | 1606 |  |  | 2025-03-07 | 2025-03-11 | 0d |  |  | 718d | 0d |  |  |  |  | SIT | 6.1 | Stuart Scott |  | 100.33 | Green | GREEN |  |  |  |  |  |
| 1608 | 1.4.3.1.1.8 | Artefact Approval (via QWG) | milestone | 0d | 2025-03-11 | 2025-03-11 | 1607 |  |  | 2025-03-11 | 2025-03-11 | 0d |  |  | 718d | 0d |  |  |  |  | SIT | 6.1 | Stuart Scott |  | 104.71 | Green | GREEN |  |  |  |  |  |
| 1609 | 1.4.3.1.1.9 | Final Document updates post QWG review |  | 1d | 2025-03-13 | 2025-03-13 | 1608FS+1d |  |  | 2025-03-13 | 2025-03-13 | 0d |  |  | 718d | 0d |  |  |  |  | SIT | 6.1 | Stuart Scott |  | 106.33 | Green | GREEN |  |  |  |  |  |
| 1610 | 1.4.3.1.1.10 | Submit final version to QAG |  | 1d? | 2025-03-17 | 2025-03-17 | 1609FS+1d |  |  | 2025-03-17 | 2025-03-17 | 0d |  |  | 718d | 0d |  |  |  |  | SIT | 6.1 | Stuart Scott |  | 110.33 | Green | GREEN |  |  |  |  |  |
| 1611 | 1.4.3.1.1.11 | E2E Sandbox guidance update approved |  | 1d? | 2025-03-24 | 2025-03-24 | 1610FS+4d |  |  | 2025-03-24 | 2025-03-24 | 0d |  |  | 718d |  |  |  |  |  | SIT | 6.1 | Stuart Scott |  | 117.33 | Green | GREEN |  |  |  |  |  |

| ID | WBS | Task | Type | Duration | Start | Finish | Predecessors | Complete | Remaining | Baseline start | Baseline finish | Baseline duration | Baseline 1 start | Baseline 1 finish | Total slack | Free slack | Constraint | Baseline cost | Responsible | Involved | Text9 | Update Version | MHHS Resource Name | MHHS Programme Phase | Text29 | Task Status | Sched Status | RAG | Milestone ID | Artefact ID | Tier |
| --- | --- | --- | --- | --- | --- | --- | --- | --- | --- | --- | --- | --- | --- | --- | --- | --- | --- | --- | --- | --- | --- | --- | --- | --- | --- | --- | --- | --- | --- | --- | --- |
| 1612 | 1.4.3.1.2 | **E2E Sandbox Test Data Approach & Plan** |  | 68d | 2025-01-13 | 2025-04-16 |  |  |  | 2023-12-05 | 2024-05-09 | 93d | 2023-03-29 | 2023-08-04 | 701d |  |  |  | N/A | N/A | SIT | 6.1 | Stuart Scott | Systems Integration Testing (SIT) | SITAG |  |  |  |  |  |  |
| 1613 | 1.4.3.1.2.1 | Develop document |  | 27d | 2025-01-13 | 2025-02-18 | 1601SS+199d |  |  | 2025-01-13 | 2025-02-18 | 68d | 2023-03-29 | 2023-06-30 | 701d | 0d | start no earlier than 2025-01-13 |  | SI Test |  | SIT | 5.0 | Stuart Scott | Systems Integration Testing (SIT) |  | 47.33 | Green | GREEN |  |  |  |
| 1614 | 1.4.3.1.2.2 | Internal SI review and updates |  | 5d | 2025-02-19 | 2025-02-25 | 1613 |  |  | 2025-02-19 | 2025-02-25 | 0d |  |  | 701d | 0d |  |  |  |  | SIT | 6.1 | Stuart Scott |  |  | 84.33 | Green | GREEN |  |  |  |
| 1615 | 1.4.3.1.2.3 | SRO / Code Bodies review |  | 5d | 2025-02-26 | 2025-03-04 | 1614 |  |  | 2025-02-26 | 2025-03-04 | 0d |  |  | 701d | 0d |  |  |  |  | SIT | 6.1 | Stuart Scott |  |  | 91.33 | Green | GREEN |  |  |  |
| 1616 | 1.4.3.1.2.4 | Submit proposed version to QWG | milestone | 0d | 2025-03-04 | 2025-03-04 | 1615 |  |  | 2025-03-04 | 2025-03-04 | 0d |  |  | 701d | 0d |  |  |  |  | SIT | 6.1 | Stuart Scott |  |  | 97.71 | Green | GREEN |  |  |  |
| 1617 | 1.4.3.1.2.5 | Discuss document at QWG | milestone | 0d | 2025-03-11 | 2025-03-11 | 1616FS+5d |  |  | 2025-03-11 | 2025-03-11 | 0d |  |  | 701d | 0d |  |  |  |  | SIT | 6.1 | Stuart Scott |  |  | 104.71 | Green | GREEN |  |  |  |
| 1618 | 1.4.3.1.2.6 | Final updates prior to consultation |  | 4d | 2025-03-12 | 2025-03-17 | 1617 |  |  | 2025-03-12 | 2025-03-17 | 0d |  |  | 701d | 0d |  |  |  |  | SIT | 6.1 | Stuart Scott |  |  | 105.33 | Green | GREEN |  |  |  |
| 1619 | 1.4.3.1.2.7 | Industry Consultation for E2E Sandbox Test Data Approach and Plan document |  | 10d | 2025-03-18 | 2025-03-31 | 1618 |  |  | 2025-03-18 | 2025-03-31 | 0d |  |  | 701d | 0d |  |  |  |  | SIT | 6.1 | Stuart Scott |  |  | 111.33 | Green | GREEN |  |  |  |
| 1620 | 1.4.3.1.2.8 | Document updates post Industry Consultation |  | 3d | 2025-04-01 | 2025-04-03 | 1619 |  |  | 2025-04-01 | 2025-04-03 | 0d |  |  | 701d | 0d | finish no earlier than 2024-04-22 |  |  |  | SIT | 6.1 | Stuart Scott |  |  | 125.33 | Green | GREEN |  |  |  |
| 1621 | 1.4.3.1.2.9 | Submit Proposed Version to QWG |  | 3d | 2025-04-04 | 2025-04-08 | 1620 |  |  | 2025-04-04 | 2025-04-08 | 0d |  |  | 701d | 0d |  |  |  |  | SIT | 6.1 | Stuart Scott |  |  | 128.33 | Green | GREEN |  |  |  |
| 1622 | 1.4.3.1.2.10 | Artefact Approval (via QWG) | milestone | 0d | 2025-04-08 | 2025-04-08 | 1621 |  |  | 2025-04-08 | 2025-04-08 | 0d |  |  | 701d | 0d |  |  |  |  | SIT | 6.1 | Stuart Scott |  |  | 132.71 | Green | GREEN |  |  |  |
| 1623 | 1.4.3.1.2.11 | Final Document updates post QWG review | milestone | 0d | 2025-04-09 | 2025-04-09 | 1622FS+1d |  |  | 2025-04-09 | 2025-04-09 | 0d |  |  | 701d | 0d | start no earlier than 2024-05-01 |  |  |  | SIT | 6.1 | Stuart Scott |  |  | 133.71 | Green | GREEN |  |  |  |
| 1624 | 1.4.3.1.2.12 | Submit final version to QAG | milestone | 0d | 2025-04-10 | 2025-04-10 | 1623FS+1d |  |  | 2025-04-10 | 2025-04-10 | 0d |  |  | 701d | 0d | start no earlier than 2024-05-02 |  |  |  | SIT | 6.1 | Stuart Scott |  |  | 134.71 | Green | GREEN |  |  |  |
| 1625 | 1.4.3.1.2.13 | E2E Sandbox Test Data Approach and Plan | milestone | 0d | 2025-04-16 | 2025-04-16 | 1624FS+4d |  |  | 2025-04-16 | 2025-04-16 | 0d |  |  | 701d |  | start no earlier than 2024-05-09 |  | SI Test |  | SIT | 6.1 | Stuart Scott |  | SITAG | 140.71 | Green | GREEN | T3-QU-0124 |  |  |
| 1626 | 1.4.3.2 | **UIT Stub Specification and Delivery** |  | 260d | 2023-12-04 A | 2024-11-29 A |  | 100% |  | 2023-12-04 | 2024-10-18 | 190d | 2023-10-27 | 2024-08-23 |  |  |  | -0 | N/A | N/A | SIT | 5.0 | N/A | Systems Integration Testing (SIT) |  |  |  |  |  |  |  |
| 1627 | 1.4.3.2.1 | **Qualification Test Stubs** |  | 260d | 2023-12-04 A | 2024-11-29 A |  | 100% |  | 2023-12-04 | 2024-10-18 | 190d | 2023-10-27 | 2024-08-23 |  |  |  | -0 | N/A | N/A | SIT | 5.16 | N/A | Systems Integration Testing (SIT) |  |  |  |  |  |  |  |
| 1628 | 1.4.3.2.1.1 | Specify |  | 44d | 2023-12-04 A | 2024-02-01 A | 513FS+13d | 100% |  | 2023-12-04 | 2024-02-01 | 44d | 2023-10-27 | 2023-12-29 |  |  |  |  | SI DevOps | Qualification,SRO | SIT | 5.0 | Lewis Hall | Systems Integration Testing (SIT) |  |  | Complete | COMPLETE |  |  |  |
| 1629 | 1.4.3.2.1.2 | Build & Test |  | 141d | 2024-02-02 A | 2024-08-16 A | 1628 | 100% |  | 2024-02-02 | 2024-08-16 | 141d | 2023-12-29 | 2024-05-24 |  |  |  |  | SI DevOps | Qualification,SRO | SIT | 5.23 | Lewis Hall | Systems Integration Testing (SIT) |  |  | Complete | COMPLETE |  |  |  |
| 1630 | 1.4.3.2.1.3 | Prepare for release |  | 75d | 2024-08-19 A | 2024-11-29 A | 1629 | 100% |  | 2024-08-19 | 2024-11-29 | 5d | 2024-07-29 | 2024-08-23 |  |  |  |  | SI DevOps | Qualification,SRO | SIT | 5.0 | Lewis Hall | Systems Integration Testing (SIT) |  |  | Complete | COMPLETE |  |  |  |
| 1631 | 1.4.3.2.1.4 | Non-SIT LDSO Test Harness Released | milestone | 0d | 2024-11-29 A | 2024-11-29 A | 1630 | 100% |  | 2024-11-29 | 2024-11-29 | 0d | 2024-08-23 | 2024-08-23 |  |  |  |  | SI DevOps | Qualification,SRO | SIT | 5.27 | Lewis Hall | Systems Integration Testing (SIT) | QAG |  | Complete | COMPLETE | T3-TE-0035 | MHHS-ART080 | T3 |
| 1632 | 1.4.3.3 | **Environments (UIT)** |  | 700d | 2022-10-31 A | 2025-07-04 |  | 46% | 380.37d | 2022-10-31 | 2025-07-04 | 680d | 2022-10-31 | 2025-06-06 | 644d |  |  | -0 | N/A | N/A | SIT | 5.0 | N/A | Systems Integration Testing (SIT) |  |  |  |  |  |  |  |
| 1633 | 1.4.3.3.1 | **Central Party (Avanade) Environments (UIT)** |  | 488d | 2022-11-16 A | 2024-09-27 |  | 99% | 0.53d | 2022-11-16 | 2024-09-27 | 493d | 2022-11-16 | 2024-10-04 | 844d |  |  | -0 | N/A | N/A | SIT | 5.28 | N/A | Systems Integration Testing (SIT) |  |  |  |  |  |  |  |
| 1634 | 1.4.3.3.1.1 | Central Party (Avandae) environment preparation (incl. security certificates and security compliance) |  | 447d | 2022-11-16 A | 2024-08-01 A | 509 | 100% |  | 2022-11-16 | 2024-08-01 | 463d | 2022-11-16 | 2024-08-23 |  |  |  |  | PP | SI Test | SIT | 5.28 | Heath Thomas | Systems Integration Testing (SIT) |  |  | Complete | COMPLETE |  |  |  |
| 1635 | 1.4.3.3.1.2 | Submit self-declaration of environment preparation complete (incl. security certificates and security compliance) to Programme for assurance |  | 447d | 2022-11-16 A | 2024-08-01 A | 1634SS | 100% |  | 2022-11-16 | 2024-08-01 | 463d | 2022-11-16 | 2024-08-23 |  |  |  |  | PP | SI Test | SIT | 5.28 | Heath Thomas | Systems Integration Testing (SIT) |  |  | Complete | COMPLETE |  |  |  |
| 1636 | 1.4.3.3.1.3 | Central Party (Avanade) UIT environment connectivity proving |  | 25d | 2024-08-26 A | 2024-09-27 A | 1648 | 100% |  | 2024-08-26 | 2024-09-27 | 25d | 2024-08-27 | 2024-09-20 |  |  |  |  | PP | SI Test | SIT | 5.28 | Heath Thomas | Systems Integration Testing (SIT) |  |  | Complete | COMPLETE |  |  |  |
| 1637 | 1.4.3.3.1.4 | Deployment of MHHS solution code to UIT environments |  | 2d | 2024-07-29 A | 2024-07-30 A |  | 100% |  | 2024-07-29 | 2024-07-30 | 10d | 2024-09-09 | 2024-09-20 |  |  | start no earlier than 2024-07-29 |  | PP | SI Test | SIT | 5.28 | Heath Thomas | Systems Integration Testing (SIT) |  |  | Complete | COMPLETE |  |  |  |
| 1638 | 1.4.3.3.1.5 | Central Party (Avanade) UIT environment Regression Testing |  | 1d | 2024-07-31 | 2024-07-31 | 1637 |  |  | 2024-07-31 | 2024-07-31 | 10d | 2024-09-23 | 2024-10-04 | 886d |  |  |  | PP | SI Test | SIT | 5.28 | Heath Thomas | Systems Integration Testing (SIT) |  | -118.67 | Overdue Start | RED |  |  |  |

| ID | WBS | Task | Type | Duration | Start | Finish | Predecessors | Complete | Remaining | Baseline start | Baseline finish | Baseline duration | Baseline 1 start | Baseline 1 finish | Total slack | Free slack | Constraint | Responsible | Involved | Text9 | Update Version | MHHS Resource Name | MHHS Programme Phase | Task Status | Sched Status | RAG | Milestone ID | Text29 | Tier | Artefact ID |
| --- | --- | --- | --- | --- | --- | --- | --- | --- | --- | --- | --- | --- | --- | --- | --- | --- | --- | --- | --- | --- | --- | --- | --- | --- | --- | --- | --- | --- | --- | --- |
| 1639 | 1.4.3.3.2 | **E2E Sandbox Participants (UIT)** |  | 680d | 2022-10-31 | 2025-06-06 |  |  |  | 2022-10-31 | 2025-06-06 | 680d | 2022-10-31 | 2025-06-06 | 0d |  |  | N/A | N/A | SIT | 5.0 | Heath Thomas | Systems Integration Testing (SIT) |  |  |  |  |  |  |  |
| 1640 | 1.4.3.3.2.1 | E2E Sandbox Participants environment preparation (incl. security certificates and security compliance) |  | 660d | 2022-10-31 | 2025-05-09 |  |  |  | 2022-10-31 | 2025-05-09 | 660d | 2022-10-31 | 2025-05-09 | 0d |  | must finish on 2025-05-09 | PP | SI Test | SIT | 5.0 | Heath Thomas | Systems Integration Testing (SIT) | -757.67 | Overdue Start | GREEN |  |  |  |  |
| 1641 | 1.4.3.3.2.2 | Submit self-declaration of environment preparation complete (incl. security certificates and security compliance) to Programme for assurance |  | 660d | 2022-10-31 | 2025-05-09 |  |  |  | 2022-10-31 | 2025-05-09 | 660d | 2022-10-31 | 2025-05-09 | 664d | 0d |  | PP | SI Test | SIT | 5.0 | Heath Thomas | Systems Integration Testing (SIT) | -757.67 | Overdue Start | GREEN |  |  |  |  |
| 1642 | 1.4.3.3.2.3 | E2E Sandbox Participants UIT environment connectivity proving |  | 20d | 2025-05-12 | 2025-06-06 | 1641 |  |  | 2025-05-12 | 2025-06-06 | 20d | 2025-05-12 | 2025-06-06 | 664d | 0d |  | PP | SI Test | SIT | 5.0 | Heath Thomas | Systems Integration Testing (SIT) | 166.33 | Green | GREEN |  |  |  |  |
| 1643 | 1.4.3.3.2.4 | Deployment of MHHS solution code to UIT environments |  | 10d | 2025-05-26 | 2025-06-06 | 1642FF |  |  | 2025-05-26 | 2025-06-06 | 10d | 2025-05-26 | 2025-06-06 | 664d |  |  | PP | SI Test | SIT | 5.0 | Heath Thomas | Systems Integration Testing (SIT) | 180.33 | Green | GREEN |  |  |  |  |
| 1644 | 1.4.3.3.2.5 | Coordinate E2E Sandbox Participants' UIT environment preparation (for E2E Sandbox Testing Start) |  | 463d | 2022-10-31 | 2024-08-07 | 1640SS |  |  | 2022-10-31 | 2024-08-07 | 463d | 2022-10-31 | 2024-08-07 | 881d |  |  | SI Test | PP | SIT | 5.0 | Heath Thomas | Systems Integration Testing (SIT) | -757.67 | Overdue Start | RED |  |  |  |  |
| 1645 | 1.4.3.3.3 | **SI Environments (UIT)** |  | 688d | 2022-11-16 A | 2025-07-04 |  | 71% | 201.67d | 2022-11-16 | 2025-07-04 | 680d | 2022-10-31 | 2025-06-06 | 644d |  |  | N/A | N/A | SIT | 5.0 | Heath Thomas | Systems Integration Testing (SIT) |  |  |  |  |  |  |  |
| 1646 | 1.4.3.3.3.1 | Coordinate Central Parties' UIT environment preparation |  | 447d | 2022-11-16 A | 2024-08-01 A | 1634SS | 100% |  | 2022-11-16 | 2024-08-01 | 463d | 2022-11-16 | 2024-08-23 |  |  |  | SI Test | PP | SIT | 5.0 | Heath Thomas | Systems Integration Testing (SIT) |  | Complete | COMPLETE |  |  |  |  |
| 1647 | 1.4.3.3.3.2 | Assure Central Parties' self-declaration of environment preparation complete (incl. security certificates and security compliance) |  | 463d | 2022-11-16 A | 2024-08-23 | 1635SS | 97% | 12d | 2022-11-16 | 2024-08-23 | 463d | 2022-11-16 | 2024-08-23 | 869d |  |  | SI Test | PP | SIT | 5.0 | Heath Thomas | Systems Integration Testing (SIT) |  | Overdue | RED |  |  |  |  |
| 1648 | 1.4.3.3.3.3 | Central Parties' UIT environments ready to start connectivity proving (incl. certificates and security compliance) | milestone | 0d | 2024-08-23 A | 2024-08-23 A | 1631 | 100% |  | 2024-08-23 | 2024-08-23 | 0d | 2024-08-23 | 2024-08-23 |  |  |  | SI Test | PP | SIT | 5.0 | Heath Thomas | Systems Integration Testing (SIT) |  | Complete | COMPLETE | T3-TE-0044 | QAG | T3 |  |
| 1649 | 1.4.3.3.3.4 | Coordinate Central Parties' UIT environment connectivity proving |  | 26d | 2024-08-26 A | 2024-09-30 A | 1636SS | 100% |  | 2024-08-26 | 2024-09-30 | 19d | 2025-05-12 | 2025-06-05 |  |  |  | SI Test | PP | SIT | 5.0 | Heath Thomas | Systems Integration Testing (SIT) |  | Complete | COMPLETE |  |  |  |  |
| 1650 | 1.4.3.3.3.5 | Coordinate deployment of MHHS solution code to Central Parties' UIT environments |  | 2d | 2024-07-29 A | 2024-07-30 A | 1637SS | 100% |  | 2024-07-29 | 2024-07-30 | 10d | 2025-05-26 | 2025-06-06 |  |  |  | SI Test | PP | SIT | 5.0 | Heath Thomas | Systems Integration Testing (SIT) |  | Complete | COMPLETE |  |  |  |  |
| 1651 | 1.4.3.3.3.6 | Coordinate Central Parties' UIT environment Regression Testing |  | 1d | 2024-07-31 | 2024-07-31 | 1650 |  |  | 2024-07-31 | 2024-07-31 | 10d | 2024-09-23 | 2024-10-04 | 886d |  |  | SI Test | PP | SIT | 5.0 | Heath Thomas | Systems Integration Testing (SIT) | -118.67 | Overdue Start | RED |  |  |  |  |
| 1652 | 1.4.3.3.3.7 | **Environments (Non-SIT LDSO)** |  | 43d | 2024-08-01 | 2024-09-30 |  |  |  | 2024-08-01 | 2024-09-30 | 115d | 2024-08-06 | 2025-01-13 | 843d |  |  | N/A | N/A | SIT | 5.28 | Heath Thomas | Qualification |  |  |  |  |  |  |  |
| 1653 | 1.4.3.3.3.7.1 | Coordinate Qualification Participants' environment preparation |  | 17d | 2024-08-01 | 2024-08-23 |  |  |  | 2024-08-01 | 2024-08-23 | 60d | 2024-08-06 | 2024-10-28 | 869d |  | start no earlier than 2024-08-01 | SI Test | Code Bodies, PP | SIT | 5.28 | Heath Thomas | Qualification | -117.67 | Overdue Start | RED |  |  |  |  |
| 1654 | 1.4.3.3.3.7.2 | Coordinate deployment of MHHS solution code to Qualification Participants' UIT environments |  | 17d | 2024-08-01 | 2024-08-23 |  |  |  | 2024-08-01 | 2024-08-23 | 10d | 2024-10-15 | 2024-10-28 | 843d | 0d | start no earlier than 2024-08-01 | SI Test | Code Bodies, PP | SIT | 5.28 | Heath Thomas | Qualification | -117.67 | Overdue Start | RED |  |  |  |  |
| 1655 | 1.4.3.3.3.7.3 | Qualification Testing Tranche 1 Participants' UIT environments ready to start connectivity proving (incl. certificates and security compliance) | milestone | 0d | 2024-08-26 | 2024-08-26 | 1654FS+1d |  |  | 2024-08-26 | 2024-08-26 | 0d | 2024-11-04 | 2024-11-04 | 843d | 0d |  | SI Test | Code Bodies, PP, IPA | SIT | 5.28 | Heath Thomas | Qualification | -92.29 | Overdue Start | RED | T3-TE-0017 | QAG | T3 | MHHS-ART073 |
| 1656 | 1.4.3.3.3.7.4 | **Coordinate Qualification Participants' connectivity proving (Non-SIT LDSO)** |  | 25d | 2024-08-27 | 2024-09-30 |  |  |  | 2024-08-27 | 2024-09-30 | 50d | 2024-11-05 | 2025-01-13 | 843d |  |  | N/A | N/A | SIT | 5.0 | Heath Thomas | Qualification |  |  |  |  |  |  |  |
| 1657 | 1.4.3.3.3.7.4.1 | Assurance of Qualification Participants' connectivity proving |  | 25d | 2024-08-27 | 2024-09-30 | 1655 |  |  | 2024-08-27 | 2024-09-30 | 50d | 2024-11-05 | 2025-01-13 | 843d |  |  | SI Test | Code Bodies, PP | SIT | 5.0 | Heath Thomas | Qualification | -91.67 | Overdue Start | RED |  |  |  |  |
| 1658 | 1.4.3.3.3.8 | **Environments (S&A) Wave 1** |  | 41d | 2024-08-01 | 2024-09-26 |  |  |  | 2024-08-01 | 2024-09-26 | 115d | 2024-08-06 | 2025-01-13 |  |  |  | N/A | N/A | SIT | 5.28 | Heath Thomas | Qualification |  |  |  |  |  |  |  |
| 1659 | 1.4.3.3.3.8.1 | Coordinate Qualification Participants' environment preparation |  | 20d | 2024-09-02 | 2024-09-27 |  |  |  | 2024-09-02 | 2024-09-27 | 60d | 2024-08-06 | 2024-10-28 | 844d |  | start no earlier than 2024-09-02 | SI Test | Code Bodies, PP | SIT | 5.28 | Heath Thomas | Qualification | -85.67 | Overdue Start | RED |  |  |  |  |
| 1660 | 1.4.3.3.3.8.2 | Coordinate deployment of MHHS solution code to Qualification Participants' UIT environments |  | 10d | 2024-10-21 | 2024-11-01 |  |  |  | 2024-10-21 | 2024-11-01 | 10d | 2024-10-15 | 2024-10-28 | 774d | 0d | start no earlier than 2024-10-21 | SI Test | Code Bodies, PP | SIT | 5.28 | Heath Thomas | Qualification | -36.67 | Overdue Start | GREEN |  |  |  |  |
| 1661 | 1.4.3.3.3.8.3 | Qualification Testing Wave 1 Participants' UIT environments ready to start connectivity proving (incl. certificates and security compliance) |  | 19d | 2024-11-05 | 2024-11-29 | 1660FS+1d |  |  | 2024-11-05 | 2024-11-29 | 0d | 2024-11-04 | 2024-11-04 | 774d | 0d |  | SI Test | Code Bodies, PP, IPA | SIT | 5.28 | Heath Thomas | Qualification | -21.67 | Green | GREEN |  | QAG | T3 | MHHS-ART073 |
| 1662 | 1.4.3.3.3.8.4 | **Coordinate Qualification Participants' connectivity proving (S&A)** |  | 25d | 2024-12-02 | 2025-01-03 |  |  |  | 2024-12-02 | 2025-01-03 | 50d | 2024-11-05 | 2025-01-13 | 774d |  |  | N/A | N/A | SIT | 5.0 | Heath Thomas | Qualification |  |  |  |  |  |  |  |
| 1663 | 1.4.3.3.3.8.4.1 | Assurance of Qualification Participants' connectivity proving |  | 25d | 2024-12-02 | 2025-01-03 | 1661 |  |  | 2024-12-02 | 2025-01-03 | 50d | 2024-11-05 | 2025-01-13 | 774d |  |  | SI Test | Code Bodies, PP | SIT | 5.0 | Heath Thomas | Qualification | 5.33 | Green | GREEN |  |  |  |  |

Notes:
- 1652: 26/11/24 - This is a duplicate, with the more up to date and accurate activity / milestone in S&A plan. QAG to confirm whether this can be removed.
- 1653: 26/11/24 - This is a duplicate, with the more up to date and accurate activity / milestone in S&A plan. QAG to confirm whether this can be removed.
- 1654: 26/11/24 - This is a duplicate, with the more up to date and accurate activity / milestone in S&A plan. QAG to confirm whether this can be removed.
- 1655: 26/11/24 - This is a duplicate, with the more up to date and accurate activity / milestone in S&A plan. QAG to confirm whether this can be removed.
- 1656: 26/11/24 - This is a duplicate, with the more up to date and accurate activity / milestone in S&A plan. QAG to confirm whether this can be removed.
- 1657: 26/11/24 - This is a duplicate, with the more up to date and accurate activity / milestone in S&A plan. QAG to confirm whether this can be removed.
- 1658: 26/11/24 - This is a duplicate, with the more up to date and accurate activity / milestone in S&A plan. QAG to confirm whether this can be removed.
- 1659: 26/11/24 - This is a duplicate, with the more up to date and accurate activity / milestone in S&A plan. QAG to confirm whether this can be removed.
- 1660: 26/11/24 - This is a duplicate, with the more up to date and accurate activity / milestone in S&A plan. QAG to confirm whether this can be removed.
- 1661: 26/11/24 - This is a duplicate, with the more up to date and accurate activity / milestone in S&A plan. QAG to confirm whether this can be removed.
- 1662: 26/11/24 - This is a duplicate, with the more up to date and accurate activity / milestone in S&A plan. QAG to confirm whether this can be removed.
- 1663: 26/11/24 - This is a duplicate, with the more up to date and accurate activity / milestone in S&A plan. QAG to confirm whether this can be removed.

| ID | WBS | Task | Duration | Start | Finish | Predecessors | Baseline start | Baseline finish | Baseline duration | Baseline 1 start | Baseline 1 finish | Total slack | Free slack | Constraint | Baseline cost | Responsible | Involved | Text9 | Update Version | MHHS Resource Name | MHHS Programme Phase | Task Status | Sched Status | RAG | Artefact ID | Text29 | Tier |
| --- | --- | --- | --- | --- | --- | --- | --- | --- | --- | --- | --- | --- | --- | --- | --- | --- | --- | --- | --- | --- | --- | --- | --- | --- | --- | --- | --- |
| 1664 | 1.4.3.3.3.9 | **Environments (S&A) Wave 2** | 139d | 2024-08-27 | 2025-03-07 |  | 2024-08-27 | 2025-03-07 | 115d | 2024-08-06 | 2025-01-13 | 0d |  |  |  | N/A | N/A | SIT | 5.28 | Heath Thomas | Qualification |  |  |  |  |  |  |
| 1665 | 1.4.3.3.3.9.1 | Coordinate Qualification Participants' environment preparation | 20d | 2024-11-18 | 2024-12-13 |  | 2024-11-18 | 2024-12-13 | 60d | 2024-08-06 | 2024-10-28 | 789d |  | start no earlier than 2024-11-18 |  | SI Test | Code Bodies, PP | SIT | 5.28 | Heath Thomas | Qualification | -8.67 | Green | GREEN |  |  |  |
| 1666 | 1.4.3.3.3.9.2 | Coordinate deployment of MHHS solution code to Qualification Participants' UIT environments | 20d | 2024-12-16 | 2025-01-10 |  | 2024-12-16 | 2025-01-10 | 10d | 2024-10-15 | 2024-10-28 | 729d | 0d | start no earlier than 2024-12-16 |  | SI Test | Code Bodies, PP | SIT | 5.28 | Heath Thomas | Qualification | 19.33 | Green | GREEN |  |  |  |
| 1667 | 1.4.3.3.3.9.3 | Qualification Testing Wave 2 Participants' UIT environments ready to start connectivity proving (incl. certificates and security compliance) | 15d | 2025-01-13 | 2025-01-31 | 1666 | 2025-01-13 | 2025-01-31 | 0d | 2024-11-04 | 2024-11-04 | 729d | 0d |  |  | SI Test | Code Bodies, PP, IPA | SIT | 5.28 | Heath Thomas | Qualification | 47.33 | Green | GREEN | MHHS-ART073 | QAG | T3 |
| 1668 | 1.4.3.3.3.9.4 | **Coordinate Qualification Participants' connectivity proving (S&A)** | 25d | 2024-08-27 | 2024-09-30 |  | 2024-08-27 | 2024-09-30 | 50d | 2024-11-05 | 2025-01-13 |  |  |  |  | N/A | N/A | SIT | 5.0 | Heath Thomas | Qualification |  |  |  |  |  |  |
| 1669 | 1.4.3.3.3.9.4.1 | Assurance of Qualification Participants' connectivity proving | 25d | 2025-02-03 | 2025-03-07 | 1667 | 2025-02-03 | 2025-03-07 | 50d | 2024-11-05 | 2025-01-13 | 729d |  |  |  | SI Test | Code Bodies, PP | SIT | 5.0 | Heath Thomas | Qualification | 68.33 | Green | GREEN |  |  |  |
| 1670 | 1.4.3.3.3.10 | **Environments (S&A) Wave 3** | 80d | 2025-03-17 | 2025-07-04 |  | 2025-03-17 | 2025-07-04 | 115d | 2024-08-06 | 2025-01-13 | 644d |  |  |  | N/A | N/A | SIT | 5.28 | Heath Thomas | Qualification |  |  |  |  |  |  |
| 1671 | 1.4.3.3.3.10.1 | Coordinate Qualification Participants' environment preparation | 30d | 2025-03-17 | 2025-04-25 |  | 2025-03-17 | 2025-04-25 | 60d | 2024-08-06 | 2024-10-28 | 694d |  | start no earlier than 2025-03-17 |  | SI Test | Code Bodies, PP | SIT | 5.28 | Heath Thomas | Qualification | 110.33 | Green | GREEN |  |  |  |
| 1672 | 1.4.3.3.3.10.2 | Coordinate deployment of MHHS solution code to Qualification Participants' UIT environments | 10d | 2025-04-28 | 2025-05-09 |  | 2025-04-28 | 2025-05-09 | 10d | 2024-10-15 | 2024-10-28 | 644d | 0d | start no earlier than 2025-04-28 |  | SI Test | Code Bodies, PP | SIT | 5.28 | Heath Thomas | Qualification | 152.33 | Green | GREEN |  |  |  |
| 1673 | 1.4.3.3.3.10.3 | Qualification Testing Wave 3 Participants' UIT environments ready to start connectivity proving (incl. certificates and security compliance) | 14d | 2025-05-13 | 2025-05-30 | 1672FS+1d | 2025-05-13 | 2025-05-30 | 0d | 2024-11-04 | 2024-11-04 | 644d | 0d |  |  | SI Test | Code Bodies, PP, IPA | SIT | 5.28 | Heath Thomas | Qualification | 167.33 | Green | GREEN | MHHS-ART073 | QAG | T3 |
| 1674 | 1.4.3.3.3.10.4 | **Coordinate Qualification Participants' connectivity proving (S&A)** | 25d | 2025-06-02 | 2025-07-04 |  | 2025-06-02 | 2025-07-04 | 50d | 2024-11-05 | 2025-01-13 | 644d |  |  |  | N/A | N/A | SIT | 5.0 | Heath Thomas | Qualification |  |  |  |  |  |  |
| 1675 | 1.4.3.3.3.10.4.1 | Assurance of Qualification Participants' connectivity proving | 25d | 2025-06-02 | 2025-07-04 | 1673 | 2025-06-02 | 2025-07-04 | 50d | 2024-11-05 | 2025-01-13 | 644d |  |  |  | SI Test | Code Bodies, PP | SIT | 5.0 | Heath Thomas | Qualification | 187.33 | Green | GREEN |  |  |  |
| 1676 | 1.4.3.3.3.11 | **Environments (S&A) Wave 4** | 80d | 2025-03-17 | 2025-07-04 |  | 2025-03-17 | 2025-07-04 | 115d | 2024-08-06 | 2025-01-13 | 55d |  |  |  | N/A | N/A | SIT | 5.28 | Heath Thomas | Qualification |  |  |  |  |  |  |
| 1677 | 1.4.3.3.3.11.1 | Coordinate Qualification Participants' environment preparation | 30d | 2025-03-17 | 2025-04-25 |  | 2025-03-17 | 2025-04-25 | 60d | 2024-08-06 | 2024-10-28 | 694d |  | finish no earlier than 2025-04-25 |  | SI Test | Code Bodies, PP | SIT | 5.28 | Heath Thomas | Qualification | 110.33 | Green | GREEN |  |  |  |
| 1678 | 1.4.3.3.3.11.2 | Coordinate deployment of MHHS solution code to Qualification Participants' UIT environments | 10d | 2025-04-28 | 2025-05-09 |  | 2025-04-28 | 2025-05-09 | 10d | 2024-10-15 | 2024-10-28 | 644d | 0d | finish no earlier than 2025-05-09 |  | SI Test | Code Bodies, PP | SIT | 5.28 | Heath Thomas | Qualification | 152.33 | Green | GREEN |  |  |  |
| 1679 | 1.4.3.3.3.11.3 | Qualification Testing Wave 4 Participants' UIT environments ready to start connectivity proving (incl. certificates and security compliance) | 14d | 2025-05-13 | 2025-05-30 | 1678FS+1d | 2025-05-13 | 2025-05-30 | 0d | 2024-11-04 | 2024-11-04 | 644d | 0d | finish no earlier than 2025-05-30 |  | SI Test | Code Bodies, PP, IPA | SIT | 5.28 | Heath Thomas | Qualification | 167.33 | Green | GREEN | MHHS-ART073 | QAG | T3 |
| 1680 | 1.4.3.3.3.11.4 | **Coordinate Qualification Participants' connectivity proving (S&A)** | 25d | 2025-06-02 | 2025-07-04 |  | 2025-06-02 | 2025-07-04 | 50d | 2024-11-05 | 2025-01-13 |  |  |  |  | N/A | N/A | SIT | 5.0 | N/A | Qualification |  |  |  |  |  |  |
| 1681 | 1.4.3.3.3.11.4.1 | Assurance of Qualification Participants' connectivity proving | 25d | 2025-06-02 | 2025-07-04 | 1679 | 2025-06-02 | 2025-07-04 | 50d | 2024-11-05 | 2025-01-13 | 644d |  | start no earlier than 2025-06-02 |  | SI Test | Code Bodies, PP | SIT | 5.0 |  | Qualification | 187.33 | Green | GREEN |  |  |  |
| 1682 | 1.4.3.4 | **Test Data** | 30d | 2024-08-26 | 2024-10-04 |  | 2024-08-26 | 2024-10-04 | 30d | 2024-08-26 | 2024-10-04 | 819d |  |  | -0 | N/A | N/A | SIT | 5.0 | N/A | Systems Integration Testing (SIT) |  |  |  |  |  |  |
| 1683 | 1.4.3.4.1 | **Central Parties (for E2E Sandbox & Qualification)** | 30d | 2024-08-26 | 2024-10-04 |  | 2024-08-26 | 2024-10-04 | 30d | 2024-08-26 | 2024-10-04 | 819d |  |  |  | N/A | N/A | SIT | 5.0 | N/A | Systems Integration Testing (SIT) |  |  |  |  |  |  |
| 1684 | 1.4.3.4.1.1 | Central Parties' UIT environment test data loading & verification (& data cleansing, if required) | 30d | 2024-08-26 | 2024-10-04 |  | 2024-08-26 | 2024-10-04 | 30d | 2024-08-26 | 2024-10-04 | 819d | 0d | start no earlier than 2024-08-26 |  | PP | SI Test | SIT | 5.0 | Richard Puddephat | Systems Integration Testing (SIT) | -92.67 | Overdue Start | RED |  |  |  |
| 1685 | 1.4.3.4.1.2 | Submit self-declaration to Programme to confirm loading & verification of test data | 30d | 2024-08-26 | 2024-10-04 | 1684SS | 2024-08-26 | 2024-10-04 | 30d | 2024-08-26 | 2024-10-04 | 819d | 0d |  |  | PP | SI Test | SIT | 5.0 | Richard Puddephat | Systems Integration Testing (SIT) | -92.67 | Overdue Start | RED |  |  |  |
| 1686 | 1.4.3.4.2 | **E2E Sandbox Participants** | 30d | 2024-08-26 | 2024-10-04 |  | 2024-08-26 | 2024-10-04 | 30d | 2024-08-26 | 2024-10-04 | 839d |  |  | -0 | N/A | N/A | SIT | 5.0 | Richard Puddephat | Systems Integration Testing (SIT) |  |  |  |  |  |  |
| 1687 | 1.4.3.4.2.1 | UIT environment test data loading and verification (and data cleansing, if required) (for E2E Sandbox Testing Start) | 30d | 2024-08-26 | 2024-10-04 | 1684FF | 2024-08-26 | 2024-10-04 | 30d | 2024-08-26 | 2024-10-04 | 839d | 0d |  |  | PP | SI Test | SIT | 5.0 | Richard Puddephat | Systems Integration Testing (SIT) | -92.67 | Overdue Start | RED |  |  |  |

Notes:
- 1664: 26/11/24 - This is a duplicate, with the more up to date and accurate activity / milestone in S&A plan. QAG to confirm whether this can be removed.
- 1665: 26/11/24 - This is a duplicate, with the more up to date and accurate activity / milestone in S&A plan. QAG to confirm whether this can be removed.
- 1666: 26/11/24 - This is a duplicate, with the more up to date and accurate activity / milestone in S&A plan. QAG to confirm whether this can be removed.
- 1667: 26/11/24 - This is a duplicate, with the more up to date and accurate activity / milestone in S&A plan. QAG to confirm whether this can be removed.
- 1668: 26/11/24 - This is a duplicate, with the more up to date and accurate activity / milestone in S&A plan. QAG to confirm whether this can be removed.
- 1669: 26/11/24 - This is a duplicate, with the more up to date and accurate activity / milestone in S&A plan. QAG to confirm whether this can be removed.
- 1670: 26/11/24 - This is a duplicate, with the more up to date and accurate activity / milestone in S&A plan. QAG to confirm whether this can be removed.
- 1671: 26/11/24 - This is a duplicate, with the more up to date and accurate activity / milestone in S&A plan. QAG to confirm whether this can be removed.
- 1672: 26/11/24 - This is a duplicate, with the more up to date and accurate activity / milestone in S&A plan. QAG to confirm whether this can be removed.
- 1673: 26/11/24 - This is a duplicate, with the more up to date and accurate activity / milestone in S&A plan. QAG to confirm whether this can be removed.
- 1674: 26/11/24 - This is a duplicate, with the more up to date and accurate activity / milestone in S&A plan. QAG to confirm whether this can be removed.
- 1675: 26/11/24 - This is a duplicate, with the more up to date and accurate activity / milestone in S&A plan. QAG to confirm whether this can be removed.
- 1676: 26/11/24 - This is a duplicate, with the more up to date and accurate activity / milestone in S&A plan. QAG to confirm whether this can be removed.
- 1677: 26/11/24 - This is a duplicate, with the more up to date and accurate activity / milestone in S&A plan. QAG to confirm whether this can be removed.
- 1678: 26/11/24 - This is a duplicate, with the more up to date and accurate activity / milestone in S&A plan. QAG to confirm whether this can be removed.
- 1679: 26/11/24 - This is a duplicate, with the more up to date and accurate activity / milestone in S&A plan. QAG to confirm whether this can be removed.
- 1680: 26/11/24 - This is a duplicate, with the more up to date and accurate activity / milestone in S&A plan. QAG to confirm whether this can be removed.
- 1681: 26/11/24 - This is a duplicate, with the more up to date and accurate activity / milestone in S&A plan. QAG to confirm whether this can be removed.

| ID | WBS | Task | Type | Duration | Start | Finish | Predecessors | Complete | Remaining | Baseline start | Baseline finish | Baseline duration | Baseline 1 start | Baseline 1 finish | Total slack | Free slack | Constraint | Baseline cost | Responsible | Involved | Text9 | Update Version | MHHS Resource Name | MHHS Programme Phase | Task Status | Sched Status | RAG | Artefact ID | Milestone ID | Text29 | Tier | Future RAG |
| --- | --- | --- | --- | --- | --- | --- | --- | --- | --- | --- | --- | --- | --- | --- | --- | --- | --- | --- | --- | --- | --- | --- | --- | --- | --- | --- | --- | --- | --- | --- | --- | --- |
| 1688 | 1.4.3.4.3 | **SI Test Data** |  | 30d | 2024-08-26 | 2024-10-04 |  |  |  | 2024-08-26 | 2024-10-04 | 30d | 2024-08-26 | 2024-10-04 | 839d |  |  |  | N/A | N/A | SIT | 5.0 | Richard Puddephat | Systems Integration Testing (SIT) |  |  |  |  |  |  |  |  |
| 1689 | 1.4.3.4.3.1 | Coordinate Central Parties' UIT environment test data loading and verification (and data cleansing, if required) |  | 30d | 2024-08-26 | 2024-10-04 | 1684SS |  |  | 2024-08-26 | 2024-10-04 | 30d | 2024-08-26 | 2024-10-04 | 839d |  |  |  | SI Test | PP | SIT | 5.0 | Richard Puddephat | Systems Integration Testing (SIT) | -92.67 | Overdue Start | RED |  |  |  |  |  |
| 1690 | 1.4.3.4.3.2 | Assure evidence of Central Parties' UIT environment test data load and verification |  | 30d | 2024-08-26 | 2024-10-04 | 1685SS |  |  | 2024-08-26 | 2024-10-04 | 30d | 2024-08-26 | 2024-10-04 | 839d |  |  |  | SI Test | PP | SIT | 5.0 | Richard Puddephat | Systems Integration Testing (SIT) | -92.67 | Overdue Start | RED |  |  |  |  |  |
| 1691 | 1.4.3.4.3.3 | Coordinate E2E Sandbox Participants' UIT environment test data loading and verification (and data cleansing, if required) (for E2E Sandbox Testing Start) |  | 30d | 2024-08-26 | 2024-10-04 | 1687SS |  |  | 2024-08-26 | 2024-10-04 | 30d | 2024-08-26 | 2024-10-04 | 839d |  |  |  | SI Test | PP | SIT | 5.0 | Richard Puddephat | Systems Integration Testing (SIT) | -92.67 | Overdue Start | RED |  |  |  |  |  |
| 1692 | 1.4.3.5 | **Other Preparation** |  | 496d | 2022-10-31 A | 2024-09-23 |  | 59% | 201.3d | 2022-10-31 | 2024-09-23 | 484d | 2022-11-16 | 2024-09-23 | 848d |  |  |  | N/A | N/A | SIT | 5.0 | N/A | Systems Integration Testing (SIT) |  |  |  |  |  |  |  |  |
| 1693 | 1.4.3.5.1 | **SI Other Preparation** |  | 66d | 2022-10-31 | 2023-01-30 |  |  |  | 2022-10-31 | 2023-01-30 | 66d | 2024-05-02 | 2024-08-01 | 1278d |  |  |  | N/A | N/A | SIT | 5.0 | N/A | Systems Integration Testing (SIT) |  |  |  |  |  |  |  |  |
| 1694 | 1.4.3.5.1.1 | Onboarding of UIT E2E Sandbox Participants to Test Management Tool for E2E Sandbox Testing Start (onboarding of participants will be ongoing hereafter) |  | 66d | 2022-10-31 | 2023-01-30 |  |  |  | 2022-10-31 | 2023-01-30 | 66d | 2024-05-02 | 2024-08-01 | 1278d | 393d |  |  | SI Test | PP | SIT | 5.0 | Stuart Scott | Systems Integration Testing (SIT) | -757.67 | Overdue Start | RED |  |  |  |  |  |
| 1695 | 1.4.3.5.2 | **Other Preparation (for Central Parties & E2E Sandbox Participants)** |  | 484d | 2022-11-16 A | 2024-09-23 |  | 67% | 161.92d | 2022-11-16 | 2024-09-23 | 484d | 2022-11-16 | 2024-09-23 | 848d |  |  |  | N/A | N/A | SIT | 5.0 | N/A | Systems Integration Testing (SIT) |  |  |  |  |  |  |  |  |
| 1696 | 1.4.3.5.2.1 | Test Management Tool onboarding for E2E Sandbox Testing Start (onboarding will be ongoing hereafter) |  | 66d | 2024-05-02 | 2024-08-01 | 1694SS |  |  | 2024-05-02 | 2024-08-01 | 66d | 2024-05-02 | 2024-08-01 | 885d |  | start no earlier than 2024-05-02 |  | PP | SI Test | SIT | 5.0 | Stuart Scott | Systems Integration Testing (SIT) | -208.67 | Overdue Start | RED |  |  |  |  |  |
| 1697 | 1.4.3.5.2.2 | Other Preparation (incl. test execution planning) |  | 484d | 2022-11-16 A | 2024-09-23 | 1634SS, 1640SS | 76% | 118d | 2022-11-16 | 2024-09-23 | 484d | 2022-11-16 | 2024-09-23 | 848d |  |  |  | PP | SI Test | SIT | 5.0 | Stuart Scott | Systems Integration Testing (SIT) |  | Overdue | RED |  |  |  |  |  |
| 1698 | 1.4.3.6 | **UIT E2E Sandbox Test Readiness Report** |  | 114d | 2024-08-26 | 2025-01-31 |  |  |  | 2024-08-26 | 2025-01-31 | 114d | 2024-08-26 | 2024-10-25 | 750d |  |  | -0 | N/A | N/A | SIT | 5.0 | N/A | Systems Integration Testing (SIT) |  |  |  |  |  |  |  |  |
| 1699 | 1.4.3.6.1 | **Central Parties E2E Sandbox Test Readiness Report** |  | 30d | 2024-08-26 | 2024-10-04 |  |  |  | 2024-08-26 | 2024-10-04 | 30d | 2024-08-26 | 2024-10-04 | 819d |  |  |  | N/A | N/A | SIT | 5.0 | N/A | Systems Integration Testing (SIT) |  |  |  |  |  |  |  |  |
| 1700 | 1.4.3.6.1.1 | Develop draft Test Readiness Report and submit to Programme for assurance |  | 20d | 2024-08-26 | 2024-09-20 | 1685FF-10d |  |  | 2024-08-26 | 2024-09-20 | 20d | 2024-08-26 | 2024-09-20 | 819d | 0d |  |  | PP | SI Test | SIT | 5.0 | Stuart Scott | Systems Integration Testing (SIT) | -92.67 | Overdue Start | RED |  |  |  |  |  |
| 1701 | 1.4.3.6.1.2 | Finalise Test Readiness Report and submit to Programme for assurance |  | 10d | 2024-09-23 | 2024-10-04 | 1685FF |  |  | 2024-09-23 | 2024-10-04 | 10d | 2024-09-23 | 2024-10-04 | 819d | 0d |  |  | PP | SI Test | SIT | 5.0 | Stuart Scott | Systems Integration Testing (SIT) | -64.67 | Overdue Start | RED |  |  |  |  |  |
| 1702 | 1.4.3.6.2 | **SI E2E Sandbox Test Readiness Report** |  | 40d | 2024-08-26 | 2024-10-18 |  |  |  | 2024-08-26 | 2024-10-18 | 40d | 2024-08-26 | 2024-10-18 | 819d |  |  |  | N/A | N/A | SIT | 5.0 | N/A | Systems Integration Testing (SIT) |  |  |  |  |  |  |  |  |
| 1703 | 1.4.3.6.2.1 | Assure Central Parties' E2E Sandbox Test Readiness Reports |  | 35d | 2024-08-26 | 2024-10-11 | 1700SS, 1701FF+5d |  |  | 2024-08-26 | 2024-10-11 | 35d | 2024-08-26 | 2024-10-11 | 819d | 0d |  |  | SI Test | PP | SIT | 5.0 | Stuart Scott | Systems Integration Testing (SIT) | -92.67 | Overdue Start | RED |  |  |  |  |  |
| 1704 | 1.4.3.6.2.2 | Develop Overarching E2E Sandbox Test Readiness Report |  | 20d | 2024-09-16 | 2024-10-11 | 1703FF |  |  | 2024-09-16 | 2024-10-11 | 20d | 2024-09-16 | 2024-10-11 | 819d | 0d |  |  | SI Test |  | SIT | 5.0 | Stuart Scott | Systems Integration Testing (SIT) | -71.67 | Overdue Start | RED |  |  |  |  |  |
| 1705 | 1.4.3.6.2.3 | Artefact review (via SITAG) and updates |  | 5d | 2024-10-14 | 2024-10-18 | 1704 |  |  | 2024-10-14 | 2024-10-18 | 5d | 2024-10-14 | 2024-10-18 | 819d | 69d |  |  | SI Test | PP,IPA | SIT | 5.0 | Stuart Scott | Systems Integration Testing (SIT) | -43.67 | Overdue Start | RED |  |  |  |  |  |
| 1706 | 1.4.3.6.3 | UIT E2E Sandbox Preparation Complete | milestone | 0d | 2025-01-31 | 2025-01-31 | 1705FS+5d |  |  | 2025-01-31 | 2025-01-31 | 0d | 2024-10-25 | 2024-10-25 | 750d | 1d | start no earlier than 2025-01-31 |  | SI Test | PP | SIT | 5.28 | Stuart Scott | Systems Integration Testing (SIT) | 65.33 | Green | GREEN | MHHS-ART154 MHHS-ART147 | T3-TE-0048 | QAG | T3 |  |
| 1707 | 1.4.4 | **SIT PPs Early Sandbox Testing Execution** |  | 316d | 2025-02-07 | 2026-04-24 |  |  |  | 2025-02-07 | 2026-04-24 | 316d | 2024-11-04 | 2026-01-19 | 434d |  |  | -0 | N/A | N/A | SIT | 5.0 | N/A | Systems Integration Testing (SIT) |  |  |  |  |  |  |  |  |
| 1708 | 1.4.4.1 | SIT PPs E2E Sandbox Testing Start | milestone | 0d | 2025-02-10 | 2025-02-10 | 1706FS+5d |  |  | 2025-02-10 | 2025-02-10 | 0d | 2024-11-04 | 2024-11-04 | 749d | 0d | start no earlier than 2025-02-10 |  | SI Test | PP | SIT | 5.28 | Stuart Scott | Systems Integration Testing (SIT) | 75.33 | Green | GREEN | MHHS-ART018 MHHS-ART154 MHHS-ART147 | T3-TE-0049 | QAG | T3 |  |
| 1709 | 1.4.4.2 | SIT PPs E2E Sandbox Testing Execution |  | 316d | 2025-02-07 | 2026-04-24 | 1708SS-1d |  |  | 2025-02-07 | 2026-04-24 | 316d | 2024-11-04 | 2026-01-19 | 434d |  | start no earlier than 2024-11-04 |  | PP | SI Test | SIT | 5.0 | Stuart Scott | Systems Integration Testing (SIT) | 72.33 | Green | GREEN |  |  |  |  |  |
| 1710 | 1.4.5 | **System Integration Testing - Tier 1 Milestones** |  | 214d? | 2025-02-27 | 2025-12-23 |  |  |  | 2025-02-28 | 2025-12-24 | 0d |  |  | 155d |  |  |  |  |  | SIT |  |  |  | -685.67 | Overdue Start |  |  |  | SITAG |  |  |
| 1711 | 1.4.5.1 | M10 Checkpoint |  | 1d? | 2025-02-27 | 2025-02-27 | 1712FS-149d |  |  | 2025-02-28 | 2025-02-28 | 0d |  |  | 735d |  |  |  | SI Test |  | SIT | 6.1 |  |  | 92.33 | Green | GREEN |  | T3-MI-0040 | SITAG |  |  |
| 1712 | 1.4.5.2 | Central systems ready for migrating MPANs (M10) | milestone | 0d | 2025-09-23 | 2025-09-23 | 1575FS+20d, 2802, 2557FS+2d, 2554, 2569, 2536, 2540 |  |  | 2025-09-24 | 2025-09-24 | 0d | 2025-03-07 | 2025-03-07 | 6d | 0d | start no earlier than 2025-08-13 |  | CPT | CPT | SIT | 6.1 | CPT | Migration | 300.71 | Green | GREEN |  | T1-MI-1000 | PSG | T1 | Central systems ready for migrating MPANs |
| 1713 | 1.4.5.3 | Central systems ready for migrating MPANs (M10*) - Late Exit | milestone | 0d | 2025-12-23 | 2025-12-23 | 1712FS+65d |  |  | 2025-12-24 | 2025-12-24 | 0d | 2025-06-06 | 2025-06-06 | 522d |  |  |  | CPT | CPT | SIT | 5.0 | CPT | Migration | 391.71 | Green | GREEN |  | T2-MI-1500 | PSG | T1 | Central systems ready for migrating MPANs |

| ID | WBS | Task | Type | Duration | Start | Finish | Predecessors | Complete | Remaining | Baseline start | Baseline finish | Baseline duration | Baseline 1 start | Baseline 1 finish | Total slack | Constraint | Baseline cost | Responsible | Involved | Text9 | Update Version | MHHS Resource Name | MHHS Programme Phase | Sched Status | RAG | Text29 | Task Status | Milestone ID | Tier |
| --- | --- | --- | --- | --- | --- | --- | --- | --- | --- | --- | --- | --- | --- | --- | --- | --- | --- | --- | --- | --- | --- | --- | --- | --- | --- | --- | --- | --- | --- |
| 1714 | 1.4.6 | **External Programme Dependency Management** |  | 174d | 2022-10-31 A | 2023-06-30 A |  | 100% |  | 2022-10-31 | 2023-06-30 | 174d | 2022-10-31 | 2023-06-30 |  |  |  | N/A | N/A | SIT | 5.0 | N/A | Systems Integration Testing (SIT) |  |  |  |  |  |  |
| 1715 | 1.4.6.1 | **BSC CP1558** |  | 173d | 2022-10-31 A | 2023-06-29 A |  | 100% |  | 2022-10-31 | 2023-06-29 | 173d | 2022-10-31 | 2023-06-29 |  |  |  | N/A | N/A | SIT | 5.0 | N/A | Systems Integration Testing (SIT) |  |  |  |  |  |  |
| 1716 | 1.4.6.1.1 | Monitor progress to implementation date |  | 173d | 2022-10-31 A | 2023-06-28 A |  | 100% |  | 2022-10-31 | 2023-06-28 | 173d | 2022-10-31 | 2023-06-28 |  |  |  | CPT | Code Bodies | SIT | 5.0 | Andrew Margan | Systems Integration Testing (SIT) | Complete | COMPLETE |  |  |  |  |
| 1717 | 1.4.6.1.2 | BSC CP1558 Implementation Date | milestone | 0d | 2023-06-29 A | 2023-06-29 A | 1716 | 100% |  | 2023-06-29 | 2023-06-29 | 0d | 2023-06-29 | 2023-06-29 |  | must start on 2023-06-29 |  | Code Bodies |  | SIT | 5.0 | Andrew Margan | Systems Integration Testing (SIT) | Complete | COMPLETE |  |  |  |  |
| 1718 | 1.4.6.2 | **REC CP R0032** |  | 174d | 2022-10-31 A | 2023-06-30 A |  | 100% |  | 2022-10-31 | 2023-06-30 | 174d | 2022-10-31 | 2023-06-30 |  |  |  | N/A | N/A | SIT | 5.0 | N/A | Systems Integration Testing (SIT) |  |  |  |  |  |  |
| 1719 | 1.4.6.2.1 | Monitor progress to implementation date |  | 174d | 2022-10-31 A | 2023-06-29 A |  | 100% |  | 2022-10-31 | 2023-06-29 | 174d | 2022-10-31 | 2023-06-29 |  |  |  | CPT | Code Bodies | SIT | 5.0 | Andrew Margan | Systems Integration Testing (SIT) | Complete | COMPLETE |  |  |  |  |
| 1720 | 1.4.6.2.2 | REC CP R0032 Implementation Date | milestone | 0d | 2023-06-30 A | 2023-06-30 A | 1719 | 100% |  | 2023-06-30 | 2023-06-30 | 0d | 2023-06-30 | 2023-06-30 |  | must start on 2023-06-30 |  | Code Bodies |  | SIT | 5.0 | Andrew Margan | Systems Integration Testing (SIT) | Complete | COMPLETE |  |  |  |  |
| 1721 | 1.4.6.3 | **REC CP R0044** |  | 173d | 2022-10-31 A | 2023-06-29 A |  | 100% |  | 2022-10-31 | 2023-06-29 | 173d | 2022-10-31 | 2023-06-29 |  |  |  | N/A | N/A | SIT | 5.0 | N/A | Systems Integration Testing (SIT) |  |  |  |  |  |  |
| 1722 | 1.4.6.3.1 | Monitor progress to implementation date |  | 173d | 2022-10-31 A | 2023-06-28 A |  | 100% |  | 2022-10-31 | 2023-06-28 | 173d | 2022-10-31 | 2023-06-28 |  |  |  | CPT | Code Bodies | SIT | 5.0 | Andrew Margan | Systems Integration Testing (SIT) | Complete | COMPLETE |  |  |  |  |
| 1723 | 1.4.6.3.2 | REC CP R0044 Implementation Date | milestone | 0d | 2023-06-29 A | 2023-06-29 A | 1722 | 100% |  | 2023-06-29 | 2023-06-29 | 0d | 2023-06-29 | 2023-06-29 |  | must start on 2023-06-29 |  | Code Bodies |  | SIT | 5.0 | Andrew Margan | Systems Integration Testing (SIT) | Complete | COMPLETE |  |  |  |  |
| 1724 | 1.5 | **NON SIT LDSO QUALIFICATION** |  | 489d? | 2023-11-07 A | 2025-09-19 |  | 70% | 149.06d? | 2023-11-07 | 2025-08-22 | 343d | 2024-01-29 | 2024-07-05 | 589d |  | -0 | N/A | N/A | Non-SIT LDSO Qualification |  | N/A | Systems Integration Testing (SIT) |  |  | QAG |  |  |  |
| 1725 | 1.5.1 | **Approach Planning** |  | 208d | 2023-11-07 A | 2024-08-22 A |  | 100% |  | 2023-11-07 | 2024-08-22 | 208d |  |  |  |  | -0 | N/A | N/A | Non-SIT LDSO Qualification | 5.24 | N/A |  |  |  |  | -386.67 |  |  |
| 1726 | 1.5.1.1 | Develop Draft Testing Approach & Plan |  | 61d | 2023-11-07 A | 2024-01-30 A |  | 100% |  | 2023-11-07 | 2024-01-30 | 61d |  |  |  | start no earlier than 2023-11-07 |  | Non-SIT LDSO | Non-SIT LDSO | Non-SIT LDSO Qualification | 5.24 | Ben Wickins |  | Complete | COMPLETE |  |  |  |  |
| 1727 | 1.5.1.2 | Draft Testing Approach & Plan Issued to LDSO for Review |  | 1d | 2024-01-31 A | 2024-01-31 A | 1726 | 100% |  | 2024-01-31 | 2024-01-31 | 1d |  |  |  |  |  | Non-SIT LDSO | Non-SIT LDSO | Non-SIT LDSO Qualification | 5.24 | Ben Wickins |  | Complete | COMPLETE |  |  |  |  |
| 1728 | 1.5.1.3 | LDSO Review Complete |  | 10d | 2024-02-01 A | 2024-02-14 A | 1727 | 100% |  | 2024-02-01 | 2024-02-14 | 10d |  |  |  |  |  | LDSOs | Non-SIT LDSO | Non-SIT LDSO Qualification | 5.24 | Ben Wickins |  | Complete | COMPLETE |  |  |  |  |
| 1729 | 1.5.1.4 | Update Following LDSO Review |  | 14d | 2024-02-15 A | 2024-03-05 A | 1728 | 100% |  | 2024-02-15 | 2024-03-05 | 14d |  |  |  |  |  | Non-SIT LDSO | Non-SIT LDSO, Code Bodies | Non-SIT LDSO Qualification | 5.24 | Ben Wickins |  | Complete | COMPLETE |  |  |  |  |
| 1730 | 1.5.1.5 | QWG Review of Approach & Plan |  | 1d | 2024-03-12 A | 2024-03-12 A | 1729FS+4d | 100% |  | 2024-03-12 | 2024-03-12 | 1d |  |  |  |  |  | Non-SIT LDSO, PP | Non-SIT LDSO, Code Bodies | Non-SIT LDSO Qualification | 5.24 | Ben Wickins |  | Complete | COMPLETE |  |  |  |  |
| 1731 | 1.5.1.6 | QAG Approval for Approach & Plan | milestone | 0d | 2024-03-21 A | 2024-03-21 A | 1730FS+7d | 100% |  | 2024-03-21 | 2024-03-21 | 0d |  |  |  |  |  | Code Bodies | Non-SIT LDSO,Code Bodies | Non-SIT LDSO Qualification | 5.24 | Ben Wickins |  | Complete | COMPLETE |  |  |  |  |
| 1732 | 1.5.1.7 | Confirmation of Participants for Non-SIT LDSO Qualification Testing | milestone | 0d | 2024-03-21 A | 2024-03-21 A | 1731 | 100% |  | 2024-03-21 | 2024-03-21 | 0d | 2024-01-29 | 2024-01-29 |  |  |  | Non-SIT LDSO | SI Test, PP, IPA | Non-SIT LDSO Qualification | 5.24 | Ben Wickins | Systems Integration Testing (SIT) | Complete | COMPLETE | QAG (Non-SIT LDSO) |  | T3-QU-0011 | T3 |
| 1733 | 1.5.1.8 | Update to Annex 1 for internal review (NF, Not Operational) |  | 15d | 2024-03-18 A | 2024-04-05 A | 1064 | 100% |  | 2024-03-18 | 2024-04-05 | 15d |  |  |  |  |  | Non-SIT LDSO | PP, Code Bodies | Non-SIT LDSO Qualification | 5.24 | Ben Wickins |  | Complete | COMPLETE |  |  |  |  |
| 1734 | 1.5.1.9 | Non-Functional, Operational & Migration Approaches Socialised with Code Bodies & LDSO & Feedback Actioned |  | 86d | 2024-04-08 A | 2024-08-05 A | 1733 | 100% |  | 2024-04-08 | 2024-08-05 | 86d |  |  |  |  |  | Non-SIT LDSO | PP, Code Bodies | Non-SIT LDSO Qualification | 5.27 | Ben Wickins |  | Complete | COMPLETE |  |  |  |  |
| 1735 | 1.5.1.10 | QWG Review Operational, Non-Functional & Migration Annexes of Approach & Plan |  | 1d | 2024-08-13 A | 2024-08-13 A | 1734FS+5d | 100% |  | 2024-08-13 | 2024-08-13 | 1d |  |  |  |  |  | Non-SIT LDSO, PP | Non-SIT LDSO, PP, Code Bodies | Non-SIT LDSO Qualification | 5.27 | Ben Wickins |  | Complete | COMPLETE |  |  |  |  |
| 1736 | 1.5.1.11 | Update Following QWG Review |  | 6d | 2024-08-14 A | 2024-08-21 A | 1735 | 100% |  | 2024-08-14 | 2024-08-21 | 6d |  |  |  |  |  | Non-SIT LDSO, PP | Non-SIT LDSO, Code Bodies | Non-SIT LDSO Qualification | 5.27 | Ben Wickins |  | Complete | COMPLETE |  |  |  |  |
| 1737 | 1.5.1.12 | QAG Approval for Operational, Non-Functional & Migration Annexes of Approach & Plan | milestone | 0d | 2024-08-22 A | 2024-08-22 A | 1736FS+1d, 1732, 1067 | 100% |  | 2024-08-22 | 2024-08-22 | 0d |  |  |  |  |  | Code Bodies | Non-SIT LDSO, Code Bodies | Non-SIT LDSO Qualification | 5.29 | Ben Wickins |  | Complete | COMPLETE | QAG (Non-SIT LDSO) |  | T3-QU-0110 |  |

Notes:
- 1733: Guidance: 26/3: Linked to the development of SIT non functional plan
- 1737: Guidance: 18/7/24: Date change from 18/7/24 to 22/8/24 approved at QAG on 18/7/24

| ID | WBS | Task | Type | Duration | Start | Finish | Predecessors | Complete | Remaining | Baseline start | Baseline finish | Baseline duration | Baseline 1 start | Baseline 1 finish | Total slack | Constraint | Baseline cost | Responsible | Involved | Text9 | Task Status | Update Version | MHHS Resource Name | Sched Status | RAG | Milestone ID | Text29 | MHHS Programme Phase | Tier |
| --- | --- | --- | --- | --- | --- | --- | --- | --- | --- | --- | --- | --- | --- | --- | --- | --- | --- | --- | --- | --- | --- | --- | --- | --- | --- | --- | --- | --- | --- |
| 1738 | 1.5.2 | **Functional Test Cases & Scenarios** |  | 58d | 2024-01-30 A | 2024-04-18 A |  | 100% |  | 2024-01-30 | 2024-04-18 | 58d |  |  |  |  | -0 | N/A | N/A | Non-SIT LDSO Qualification | -385.67 | 5.24 | N/A |  |  |  |  |  |  |
| 1739 | 1.5.2.1 | **Functional Test Cases & Scenarios Batch 1** |  | 8d | 2024-01-30 A | 2024-02-08 A |  | 100% |  | 2024-01-30 | 2024-02-08 | 8d |  |  |  |  | -0 | N/A | N/A | Non-SIT LDSO Qualification |  | 5.24 | N/A |  |  |  |  |  |  |
| 1740 | 1.5.2.1.1 | Walkthrough Test Cases & Scenarios Batch 1 with Code Bodies |  | 1d | 2024-01-30 A | 2024-01-30 A | 1726SS+60d | 100% |  | 2024-01-30 | 2024-01-30 | 1d |  |  |  |  |  | Non-SIT LDSO | Non-SIT LDSO, Code Bodies | Non-SIT LDSO Qualification |  | 5.24 | Ben Wickins | Complete | COMPLETE |  |  |  |  |
| 1741 | 1.5.2.1.2 | Walkthrough Test Cases & Scenarios Batch 1 with LDSO |  | 1d | 2024-02-01 A | 2024-02-01 A | 1740 | 100% |  | 2024-02-01 | 2024-02-01 | 1d |  |  |  |  |  | LDSO, Non-SIT LDSO | LDSO, Non-SIT LDSO | Non-SIT LDSO Qualification |  | 5.24 | Ben Wickins | Complete | COMPLETE |  |  |  |  |
| 1742 | 1.5.2.1.3 | Action Feedback on Test Cases & Scenarios Batch 1 |  | 5d | 2024-02-02 A | 2024-02-08 A | 1741 | 100% |  | 2024-02-02 | 2024-02-08 | 5d |  |  |  |  |  | Non-SIT LDSO | Non-SIT LDSO, LDSO , Code Bodies | Non-SIT LDSO Qualification |  | 5.24 | Ben Wickins | Complete | COMPLETE |  |  |  |  |
| 1743 | 1.5.2.2 | **Functional Test Cases & Scenarios Batch 2** |  | 14d | 2024-02-20 A | 2024-03-08 A |  | 100% |  | 2024-02-20 | 2024-03-08 | 14d |  |  |  |  | -0 | N/A | N/A | Non-SIT LDSO Qualification |  | 5.24 | N/A |  |  |  |  |  |  |
| 1744 | 1.5.2.2.1 | Walkthrough Test Cases & Scenarios Batch 2 with Code Bodies |  | 1d | 2024-02-20 A | 2024-02-20 A | 1726SS+75d | 100% |  | 2024-02-20 | 2024-02-20 | 1d |  |  |  |  |  | Non-SIT LDSO | Non-SIT LDSO, Code Bodies | Non-SIT LDSO Qualification |  | 5.24 | Ben Wickins | Complete | COMPLETE |  |  |  |  |
| 1745 | 1.5.2.2.2 | Walkthrough Test Cases & Scenarios Batch 2 with LDSO |  | 1d | 2024-03-01 A | 2024-03-01 A | 1744FS+7d | 100% |  | 2024-03-01 | 2024-03-01 | 1d |  |  |  |  |  | LDSO, Non-SIT LDSO | LDSO, Non-SIT LDSO | Non-SIT LDSO Qualification |  | 5.24 | Ben Wickins | Complete | COMPLETE |  |  |  |  |
| 1746 | 1.5.2.2.3 | Action Feedback on Test Cases & Scenarios Batch 2 |  | 5d | 2024-03-04 A | 2024-03-08 A | 1745 | 100% |  | 2024-03-04 | 2024-03-08 | 5d |  |  |  |  |  | Non-SIT LDSO | Non-SIT LDSO, LDSO , Code Bodies | Non-SIT LDSO Qualification |  | 5.24 | Ben Wickins | Complete | COMPLETE |  |  |  |  |
| 1747 | 1.5.2.3 | **Functional Test Cases & Scenarios Batch 3** |  | 13d | 2024-03-20 A | 2024-04-05 A |  | 100% |  | 2024-03-20 | 2024-04-05 | 13d |  |  |  |  | -0 | N/A | N/A | Non-SIT LDSO Qualification |  | 5.24 | N/A |  |  |  |  |  |  |
| 1748 | 1.5.2.3.1 | Walkthrough Test Cases & Scenarios Batch 3 with Code Bodies |  | 1d | 2024-03-20 A | 2024-03-20 A | 1726SS+96d | 100% |  | 2024-03-20 | 2024-03-20 | 1d |  |  |  |  |  | Non-SIT LDSO | Non-SIT LDSO, Code Bodies | Non-SIT LDSO Qualification |  | 5.24 | Ben Wickins | Complete | COMPLETE |  |  |  |  |
| 1749 | 1.5.2.3.2 | Walkthrough Test Cases & Scenarios Batch 3 with LDSO |  | 1d | 2024-03-28 A | 2024-03-28 A | 1748FS+5d | 100% |  | 2024-03-28 | 2024-03-28 | 1d |  |  |  |  |  | LDSO, Non-SIT LDSO | LDSO, Non-SIT LDSO | Non-SIT LDSO Qualification |  | 5.24 | Ben Wickins | Complete | COMPLETE |  |  |  |  |
| 1750 | 1.5.2.3.3 | Action Feedback on Test Cases & Scenarios Batch 3 |  | 6d | 2024-03-29 A | 2024-04-05 A | 1749 | 100% |  | 2024-03-29 | 2024-04-05 | 6d |  |  |  |  |  | Non-SIT LDSO | Non-SIT LDSO, LDSO , Code Bodies | Non-SIT LDSO Qualification |  | 5.24 | Ben Wickins | Complete | COMPLETE |  |  |  |  |
| 1751 | 1.5.2.4 | Test Cases & Scenarios Batch 1-3 Discussion at QWG |  | 1d | 2024-04-09 A | 2024-04-09 A | 1742, 1746, 1750FS+1d | 100% |  | 2024-04-09 | 2024-04-09 | 1d |  |  |  |  |  | Non-SIT LDSO, PP | Non-SIT LDSO, Code Bodies | Non-SIT LDSO Qualification |  | 5.24 | Ben Wickins | Complete | COMPLETE |  |  |  |  |
| 1752 | 1.5.2.5 | Action QWG Feedback on Test Cases & Scenarios Batch 1-3 |  | 2d | 2024-04-10 A | 2024-04-11 A | 1751 | 100% |  | 2024-04-10 | 2024-04-11 | 2d |  |  |  |  |  | Non-SIT LDSO | Non-SIT LDSO, Code Bodies | Non-SIT LDSO Qualification |  | 5.24 | Ben Wickins | Complete | COMPLETE |  |  |  |  |
| 1753 | 1.5.2.6 | Batch 1-3 Non-SIT LDSO QT Functional Test Scenarios and Test Cases approved | milestone | 0d | 2024-04-18 A | 2024-04-18 A | 1752FS+5d | 100% |  | 2024-04-18 | 2024-04-18 | 0d |  |  |  |  |  | Code Bodies | Non-SIT LDSO, Code Bodies | Non-SIT LDSO Qualification |  | 5.24 | Ben Wickins | Complete | COMPLETE | T3-QU-0069 | QAG (Non-SIT LDSO) |  |  |
| 1754 | 1.5.3 | **Test Execution Schedule** |  | 161d | 2024-04-19 A | 2024-11-29 |  | 99% | 0d | 2024-04-19 | 2024-11-29 | 90d | 2024-01-29 | 2024-04-26 | 799d |  | -0 | N/A | N/A | Non-SIT LDSO Qualification |  | 5.24 | N/A |  |  |  |  | Systems Integration Testing (SIT) |  |
| 1755 | 1.5.3.1 | Draft Test Delivery Schedule for Functional and Operational Testing |  | 20d | 2024-04-19 A | 2024-05-16 A | 1753 | 100% |  | 2024-04-19 | 2024-05-16 | 20d | 2024-01-29 | 2024-03-22 |  |  |  | Non-SIT LDSO | SI Test, PP, Non-SIT LDSO | Non-SIT LDSO Qualification |  | 5.24 | Ben Wickins | Complete | COMPLETE |  |  | Systems Integration Testing (SIT) |  |
| 1756 | 1.5.3.2 | Socialise Test Delivery Schedule with Code Bodies & LDSO for Review & Action Feedback |  | 37d | 2024-05-17 A | 2024-07-08 A | 1755 | 100% |  | 2024-05-17 | 2024-07-08 | 37d |  |  |  |  |  | Non-SIT LDSO | LDSO, Code Bodies, Non-SIT LDSO | Non-SIT LDSO Qualification |  | 5.24 | Ben Wickins | Complete | COMPLETE |  |  |  |  |
| 1757 | 1.5.3.3 | Agree Test Execution Timetable Format at QWG, Including Anonymisation Requirements |  | 1d | 2024-07-09 A | 2024-07-09 A | 1756 | 100% |  | 2024-07-09 | 2024-07-09 | 1d | 2024-03-25 | 2024-04-19 |  |  |  | Non-SIT LDSO, PP | Non-SIT LDSO, Code Bodies | Non-SIT LDSO Qualification |  | 5.24 | Ben Wickins | Complete | COMPLETE |  |  | Systems Integration Testing (SIT) |  |
| 1758 | 1.5.3.4 | Action QWG Feedback |  | 3d | 2024-07-10 A | 2024-07-12 A | 1757 | 100% |  | 2024-07-10 | 2024-07-12 | 3d |  |  |  |  |  | Non-SIT LDSO, PP | Non-SIT LDSO, Code Bodies | Non-SIT LDSO Qualification |  | 5.24 | Ben Wickins | Complete | COMPLETE |  |  |  |  |
| 1759 | 1.5.3.5 | Agree Test Execution Timetable Format at QAG, Including Anonymisation Requirements | milestone | 0d | 2024-07-18 A | 2024-07-18 A | 1758FS+4d | 100% |  | 2024-07-18 | 2024-07-18 | 0d |  |  |  |  |  | Code Bodies | Non-SIT LDSO, Code Bodies | Non-SIT LDSO Qualification |  | 5.29 | Ben Wickins | Complete | COMPLETE | T3-QU-0111 | QAG (Non-SIT LDSO) |  |  |
| 1760 | 1.5.3.6 | Qualification Testing for Non-SIT LDSOs (Functional, Migration, NFT, Operational) Test Execution Schedule Complete | milestone | 0d | 2024-11-29 | 2024-11-29 | 1737 |  |  | 2024-11-29 | 2024-11-29 | 0d | 2024-04-26 | 2024-04-26 | 799d | finish no earlier than 2024-11-29 |  | Non-SIT LDSO | Non-SIT LDSO, Code Bodies, PP | Non-SIT LDSO Qualification | 2.71 | 5.29 | Ben Wickins | Green | GREEN | T3-QU-0008 | QAG (Non-SIT LDSO) | Systems Integration Testing (SIT) | T3 |
| 1761 | 1.5.4 | **Functional, Non-Functional, Operational & Migration Test Scenarios & Cases** |  | 110d | 2024-03-22 A | 2024-08-22 A |  | 100% |  | 2024-03-22 | 2024-08-22 | 110d |  |  |  |  | -0 | N/A | N/A | Non-SIT LDSO Qualification |  | 5.24 | N/A |  |  |  |  |  |  |
| 1762 | 1.5.4.1 | Test Scenarios & Cases - Functional - Drafted, Reviewed |  | 14d | 2024-04-01 A | 2024-04-18 A | 1731 | 100% |  | 2024-04-01 | 2024-04-18 | 14d |  |  |  |  |  | Non-SIT LDSO | Non-SIT LDSO, LDSO, Code Bodies | Non-SIT LDSO Qualification |  | 5.24 | Ben Wickins | Complete | COMPLETE |  |  |  |  |
| 1763 | 1.5.4.2 | Test Scenarios & Cases- Functional - Approved at QAG | milestone | 0d | 2024-04-18 A | 2024-04-18 A | 1762 | 100% |  | 2024-04-18 | 2024-04-18 | 0d |  |  |  |  |  | Non-SIT LDSO | Non-SIT LDSO, LDSO, Code Bodies | Non-SIT LDSO Qualification |  | 5.24 | Ben Wickins | Complete | COMPLETE | T3-QU-0070 | QAG (Non-SIT LDSO) |  |  |
| 1764 | 1.5.4.3 | Test Scenarios & Cases - Non-Functional - Drafted, Reviewed |  | 110d | 2024-03-22 A | 2024-08-22 A | 1731, 1084FF | 100% |  | 2024-03-22 | 2024-08-22 | 110d |  |  |  |  |  | Non-SIT LDSO | Non-SIT LDSO, LDSO, Code Bodies | Non-SIT LDSO Qualification |  | 5.24 | Ben Wickins | Complete | COMPLETE |  |  |  |  |
| 1765 | 1.5.4.4 | Test Scenarios & Cases - Non-Functional - Approved at QAG | milestone | 0d | 2024-08-22 A | 2024-08-22 A | 1764 | 100% |  | 2024-08-22 | 2024-08-22 | 0d |  |  |  |  |  | Non-SIT LDSO | Non-SIT LDSO, LDSO, Code Bodies | Non-SIT LDSO Qualification |  | 5.29 | Ben Wickins | Complete | COMPLETE | T3-QU-0071 | QAG (Non-SIT LDSO) |  |  |
| 1766 | 1.5.4.5 | Test Scenarios & Cases - Migration - Drafted, Reviewed |  | 45d | 2024-03-22 A | 2024-05-23 A | 1731 | 100% |  | 2024-03-22 | 2024-05-23 | 45d |  |  |  |  |  | Non-SIT LDSO | Non-SIT LDSO, LDSO, Code Bodies | Non-SIT LDSO Qualification |  | 5.24 | Ben Wickins | Complete | COMPLETE |  |  |  |  |
| 1767 | 1.5.4.6 | Test Scenarios & Cases - Migration - Approved at QAG | milestone | 0d | 2024-05-23 A | 2024-05-23 A | 1766 | 100% |  | 2024-05-23 | 2024-05-23 | 0d |  |  |  |  |  | Non-SIT LDSO | Non-SIT LDSO, LDSO, Code Bodies | Non-SIT LDSO Qualification |  | 5.24 | Ben Wickins | Complete | COMPLETE | T3-QU-0072 | QAG (Non-SIT LDSO) |  |  |
| 1768 | 1.5.4.7 | Test Scenarios & Cases - Operational - Drafted, Reviewed |  | 59d | 2024-06-03 A | 2024-08-22 A | 1731FS+51d | 100% |  | 2024-06-03 | 2024-08-22 | 59d |  |  |  |  |  | Non-SIT LDSO | Non-SIT LDSO, LDSO, Code Bodies | Non-SIT LDSO Qualification |  | 5.24 | Ben Wickins | Complete | COMPLETE |  |  |  |  |
| 1769 | 1.5.4.8 | Test Scenarios & Cases - Operational - Approved at QAG | milestone | 0d | 2024-08-22 A | 2024-08-22 A | 1768, 1084FF | 100% |  | 2024-08-22 | 2024-08-22 | 0d |  |  |  |  |  | Non-SIT LDSO | Non-SIT LDSO, LDSO, Code Bodies | Non-SIT LDSO Qualification |  | 5.29 | Ben Wickins | Complete | COMPLETE | T3-QU-0073 | QAG (Non-SIT LDSO) |  |  |

Notes:
- 1760: Guidance: 18/7/24: Date change from 15/8/24 to 22/8/24 approved at QAG on 18/7/24
- 1765: Guidance: 18/7/24: Date change from 18/7/24 to 22/8/24 approved at QAG on 18/7/24
- 1769: Guidance: 18/7/24: Date change from 18/7/24 to 22/8/24 approved at QAG on 18/7/24

| ID | WBS | Task | Type | Duration | Start | Finish | Predecessors | Complete | Remaining | Baseline start | Baseline finish | Baseline duration | Total slack | Free slack | Constraint | Deadline | Baseline cost | Responsible | Involved | Text9 | Task Status | Update Version | MHHS Resource Name | Sched Status | RAG | Milestone ID | Text29 |
| --- | --- | --- | --- | --- | --- | --- | --- | --- | --- | --- | --- | --- | --- | --- | --- | --- | --- | --- | --- | --- | --- | --- | --- | --- | --- | --- | --- |
| 1770 | 1.5.5 | **Test Data** |  | 345d | 2024-01-22 A | 2025-05-16 |  | 58% | 144.8d | 2024-01-22 | 2025-05-16 | 241d | 679d |  |  |  | -0 | N/A | N/A | Non-SIT LDSO Qualification | -385.67 | 5.24 | N/A |  |  |  |  |
| 1771 | 1.5.5.1 | Test Data Plan Drafted & Reviewed |  | 89d | 2024-01-22 A | 2024-05-23 A | 1726 | 100% |  | 2024-01-22 | 2024-05-23 | 89d |  |  |  |  |  | Code Bodies | Non-SIT LDSO, Code Bodies | Non-SIT LDSO Qualification |  | 5.24 | Ben Wickins | Complete | COMPLETE |  |  |
| 1772 | 1.5.5.2 | Non-SIT LDSO QT Test Data Plan Approved by QAG | milestone | 0d | 2024-05-23 A | 2024-05-23 A | 1771 | 100% |  | 2024-05-23 | 2024-05-23 | 0d |  |  |  |  |  | Code Bodies | Non-SIT LDSO, Code Bodies | Non-SIT LDSO Qualification |  | 5.24 | Ben Wickins | Complete | COMPLETE | T3-QU-0074 | QAG (Non-SIT LDSO) |
| 1773 | 1.5.5.3 | Develop Test Data Matrices |  | 10d | 2024-05-24 A | 2024-06-06 A | 1772 | 100% |  | 2024-05-24 | 2024-06-06 | 10d |  |  |  |  |  | Non-SIT LDSO | Non-SIT LDSO | Non-SIT LDSO Qualification |  | 5.24 | Ben Wickins | Complete | COMPLETE |  |  |
| 1774 | 1.5.5.4 | Test Data Cut |  | 17d | 2024-05-24 A | 2024-06-17 A | 1772 | 100% |  | 2024-05-24 | 2024-06-17 | 17d |  |  |  |  |  | PP, Non-SIT LDSO | PP, Non-SIT LDSO | Non-SIT LDSO Qualification |  | 5.24 | Ben Wickins | Complete | COMPLETE |  |  |
| 1775 | 1.5.5.5 | Test Data Cut Complete | milestone | 0d | 2024-06-17 A | 2024-06-17 A | 1774, 1773 | 100% |  | 2024-06-17 | 2024-06-17 | 0d |  |  |  |  |  | PP, Non-SIT LDSO | PP, Non-SIT LDSO | Non-SIT LDSO Qualification |  | 5.27 | Ben Wickins | Complete | COMPLETE | T3-QU-0112 | QAG (Non-SIT LDSO) |
| 1776 | 1.5.5.6 | Test Data Reviewed by the Programme |  | 39d | 2024-06-18 A | 2024-08-09 A | 1775 | 100% |  | 2024-06-18 | 2024-08-09 | 39d |  |  |  |  |  | Non-SIT LDSO | PP, Non-SIT LDSO | Non-SIT LDSO Qualification |  | 5.24 | Ben Wickins | Complete | COMPLETE |  |  |
| 1777 | 1.5.5.7 | Test Data Loaded |  | 85d | 2024-08-12 A | 2024-12-06 | 1776 | 60% | 34d | 2024-08-12 | 2024-12-06 | 17d | 679d | 0d |  |  |  | Non-SIT LDSO | PP, Non-SIT LDSO | Non-SIT LDSO Qualification |  | 5.24 | Ben Wickins | Green | GREEN |  |  |
| 1778 | 1.5.5.8 | Test Data Signed Off | milestone | 0d | 2024-12-06 | 2024-12-06 | 1777 |  |  | 2024-12-06 | 2024-12-06 | 0d | 679d | 0d |  |  |  | Non-SIT LDSO | PP, Non-SIT LDSO | Non-SIT LDSO Qualification | 9.71 | 5.25 | Ben Wickins | Green | GREEN | T3-QU-0113 | QAG (Non-SIT LDSO) |
| 1779 | 1.5.5.9 | Test Execution Data Support |  | 115d | 2024-12-09 | 2025-05-16 | 1778 |  |  | 2024-12-09 | 2025-05-16 | 79d | 679d |  |  |  |  | Non-SIT LDSO | Non-SIT LDSO | Non-SIT LDSO Qualification | 12.33 | 5.24 | Ben Wickins | Green | GREEN |  |  |
| 1780 | 1.5.6 | **Tooling** |  | 148d | 2024-01-31 A | 2024-08-23 A |  | 100% |  | 2024-01-31 | 2024-08-23 | 148d |  |  |  |  | -0 | N/A | N/A | Non-SIT LDSO Qualification | -385.67 | 5.24 | N/A |  |  |  |  |
| 1781 | 1.5.6.1 | Design Approach & Set-Up ADO Tool for Test & Defect Management Tool |  | 53d | 2024-01-31 A | 2024-04-12 A | 1726 | 100% |  | 2024-01-31 | 2024-04-12 | 53d |  |  |  |  |  | Non-SIT LDSO | Non-SIT LDSO, SI Test | Non-SIT LDSO Qualification |  | 5.24 | Ben Wickins | Complete | COMPLETE |  |  |
| 1782 | 1.5.6.2 | Develop Training Requirements & Materials Inc. Day in the Life |  | 87d | 2024-04-15 A | 2024-08-13 A | 1781 | 100% |  | 2024-04-15 | 2024-08-13 | 87d |  |  |  |  |  | Non-SIT LDSO | Non-SIT LDSO, SI Test | Non-SIT LDSO Qualification |  | 5.24 | Ben Wickins | Complete | COMPLETE |  |  |
| 1783 | 1.5.6.3 | ADO Launch complete |  | 1d | 2024-08-23 A | 2024-08-23 A | 1782, 1763, 1767, 1769 | 100% |  | 2024-08-23 | 2024-08-23 | 1d |  |  |  |  |  | Non-SIT LDSO | Non-SIT LDSO | Non-SIT LDSO Qualification |  | 5.24 | Ben Wickins | Complete | COMPLETE |  |  |
| 1784 | 1.5.7 | **Pre-Integration Testing** |  | 258d | 2024-01-31 A | 2025-01-24 |  | 78% | 56.46d | 2024-01-31 | 2024-11-29 | 174d | 759d |  |  |  | -0 | N/A | N/A | Non-SIT LDSO Qualification | -385.67 | 5.24 | N/A |  |  |  |  |
| 1785 | 1.5.7.1 | PIT Guidance & Templates & Approach & Plans Developed |  | 106d | 2024-02-05 A | 2024-07-01 A | 1726FS+3d | 100% |  | 2024-02-05 | 2024-07-01 | 106d |  |  |  |  |  | Non-SIT LDSO | Non-SIT LDSO, LDSO | Non-SIT LDSO Qualification |  | 5.27 | Ben Wickins | Complete | COMPLETE |  |  |
| 1786 | 1.5.7.2 | PIT Test Approach & Plan Deadline for Submission for Non-SIT LDSO​ QT | milestone | 0d | 2024-07-01 A | 2024-07-01 A | 1785 | 100% |  | 2024-07-01 | 2024-07-01 | 0d |  |  |  |  |  | Non-SIT LDSO | Non-SIT LDSO, LDSO | Non-SIT LDSO Qualification |  | 5.28 | Ben Wickins | Complete | COMPLETE | T3-QU-0075 | QAG (Non-SIT LDSO) |
| 1787 | 1.5.7.3 | Develop and agree PIT Test Scenarios |  | 20d | 2024-07-02 A | 2024-07-29 A | 1786 | 100% |  | 2024-07-02 | 2024-07-29 | 31d |  |  |  |  |  | Non-SIT LDSO | Non-SIT LDSO, Code Bodies, LDSO | Non-SIT LDSO Qualification |  | 5.24 | Ben Wickins | Complete | COMPLETE |  |  |
| 1788 | 1.5.7.4 | PIT Execution (Functional and Migration) | manual | 45d | 2024-09-30 A | 2024-11-29 | 1787 | 36% | 29d | 2024-09-30 | 2024-11-29 | 45d |  |  | start no earlier than 2024-09-30 |  |  | Non-SIT LDSO | Non-SIT LDSO, LDSO | Non-SIT LDSO Qualification |  | 5.24 | Ben Wickins | Green | RED |  |  |
| 1789 | 1.5.7.5 | PIT Execution (Non-Functional and Operational) |  | 90d | 2024-09-23 A | 2025-01-24 | 1787 | 21% | 71d | 2024-09-23 | 2025-01-24 | 0d | 724d | 0d |  |  |  |  |  | Non-SIT LDSO Qualification |  |  |  | Green | GREEN |  |  |
| 1790 | 1.5.7.6 | Non-SIT LDSO Participants have submitted functional PIT Test Completion Report & evidence for QT Entry​ | milestone | 0d | 2024-11-29 | 2024-11-29 | 1788 |  |  | 2024-11-29 | 2024-11-29 | 0d | 799d | 15d |  |  |  | Non-SIT LDSO | Non-SIT LDSO, LDSO | Non-SIT LDSO Qualification | 2.71 | 5.24 | Ben Wickins | Green | RED | T3-QU-0076 | QAG (Non-SIT LDSO) |
| 1791 | 1.5.7.7 | Non-SIT LDSO Participants have submitted non-functional PIT Test Completion Report | milestone | 0d | 2025-01-24 | 2025-01-24 | 1789 |  |  | 2025-01-27 | 2025-01-27 | 0d | 724d | 60d |  |  |  |  |  | Non-SIT LDSO Qualification | 58.71 | 5.24 |  | Green | GREEN |  |  |
| 1792 | 1.5.7.8 | **Placing Reliance - Code Body & LDSO Functional and Migration** |  | 147d | 2024-01-31 A | 2024-08-22 A |  | 100% |  | 2024-01-31 | 2024-08-22 | 147d |  |  |  |  | -0 | N/A | N/A | Non-SIT LDSO Qualification | -100.67 | 5.24 | N/A |  |  |  |  |
| 1793 | 1.5.7.8.1 | Placing Reliance Submitted & Reviewed |  | 21d | 2024-01-31 A | 2024-02-28 A | 1726 | 100% |  | 2024-01-31 | 2024-02-28 | 21d |  |  |  | 2024-01-05 |  | LDSO, Non-SIT LDSO | LDSO, Non-SIT LDSO | Non-SIT LDSO Qualification |  | 5.24 | Ben Wickins | Complete | COMPLETE |  |  |
| 1794 | 1.5.7.8.2 | Define & Agree QT Testing for Each LDSO |  | 22d | 2024-02-29 A | 2024-03-29 A | 1793 | 100% |  | 2024-02-29 | 2024-03-29 | 22d |  |  |  |  |  | Non-SIT LDSO | LDSO, Non-SIT LDSO | Non-SIT LDSO Qualification |  | 5.24 | Ben Wickins | Complete | COMPLETE |  |  |
| 1795 | 1.5.7.8.3 | Develop Test Scope & Reliance Submissions |  | 20d | 2024-04-01 A | 2024-04-26 A | 1794 | 100% |  | 2024-04-01 | 2024-04-26 | 20d |  |  |  |  |  | Non-SIT LDSO | LDSO, Non-SIT LDSO, Code Bodies | Non-SIT LDSO Qualification |  | 5.24 | Ben Wickins | Complete | COMPLETE |  |  |
| 1796 | 1.5.7.8.4 | Review and Consultation |  | 84d | 2024-04-29 A | 2024-08-22 A | 1795, 1737FF | 100% |  | 2024-04-29 | 2024-08-22 | 84d |  |  |  |  |  | Non-SIT LDSO | LDSO, Non-SIT LDSO | Non-SIT LDSO Qualification |  | 5.27 | Ben Wickins | Complete | COMPLETE |  |  |

Notes:
- 1788: 25/11/24 - At least one participant is expecting to complete PIT in January, hence why this is Red. This will impact their start of QT, however, we still believe they will complete within the QT window, hence why that RAG is unaffected by this.
- 1789: 21/10/24 - Proposed to add this as a new activity, to go to QAG for approval.
- 1790: 25/11/24 - At least one participant is expecting to complete PIT in January, hence why this is Red. This will impact their start of QT, however, Programme believes they will complete within the QT window, hence why the QT window RAG is unaffected by this.
- 1791: 21/10/24 - Proposed to add this as a new activity, to go to QAG for approval.

| ID | WBS | Task | Type | Duration | Start | Finish | Predecessors | Complete | Remaining | Baseline start | Baseline finish | Baseline duration | Baseline 1 start | Baseline 1 finish | Total slack | Free slack | Constraint | Baseline cost | Responsible | Involved | Text9 | Task Status | Update Version | MHHS Resource Name | Sched Status | RAG | Milestone ID | Text29 | MHHS Programme Phase | Action | Tier |
| --- | --- | --- | --- | --- | --- | --- | --- | --- | --- | --- | --- | --- | --- | --- | --- | --- | --- | --- | --- | --- | --- | --- | --- | --- | --- | --- | --- | --- | --- | --- | --- |
| 1797 | 1.5.7.9 | **Placing Reliance - Code Body & LDSO Non Functional and Operational** |  | 49d | 2024-06-17 A | 2024-08-22 A |  | 100% |  | 2024-06-17 | 2024-08-22 | 49d |  |  |  |  |  | -0 | N/A | N/A | Non-SIT LDSO Qualification | -100.67 | 5.25 | N/A |  |  |  |  |  |  |  |
| 1798 | 1.5.7.9.1 | Placing Reliance Submitted & Reviewed |  | 32d | 2024-06-17 A | 2024-07-30 A | 1735FF-10d | 100% |  | 2024-06-17 | 2024-07-30 | 32d |  |  |  |  |  |  | LDSO, Non-SIT LDSO | LDSO, Non-SIT LDSO | Non-SIT LDSO Qualification |  | 5.27 | Ben Wickins | Complete | COMPLETE |  |  |  |  |  |
| 1799 | 1.5.7.9.2 | Review and Consultation |  | 17d | 2024-07-31 A | 2024-08-22 A | 1798 | 100% |  | 2024-07-31 | 2024-08-22 | 17d |  |  |  |  |  |  | Non-SIT LDSO | LDSO, Non-SIT LDSO | Non-SIT LDSO Qualification |  | 5.27 | Ben Wickins | Complete | COMPLETE |  |  |  |  |  |
| 1800 | 1.5.7.9.3 | PP Test Scope Presented at QAG | milestone | 0d | 2024-08-22 A | 2024-08-22 A | 1799, 1796 | 100% |  | 2024-08-22 | 2024-08-22 | 0d |  |  |  |  |  |  | Non-SIT LDSO | LDSO, Non-SIT LDSO | Non-SIT LDSO Qualification |  | 5.29 | Ben Wickins | Complete | COMPLETE | T3-QU-0077 | QAG (Non-SIT LDSO) |  |  |  |
| 1801 | 1.5.8 | **LDSO Test Readiness Reporting** |  | 71d | 2024-04-19 A | 2024-07-26 A |  | 100% |  | 2024-04-19 | 2024-07-26 | 118d |  |  |  |  |  | -0 | N/A | N/A | Non-SIT LDSO Qualification |  | 5.24 | N/A |  |  |  |  |  |  |  |
| 1802 | 1.5.8.1 | Interim Test Readiness Report & Plan Developed & Reviewed |  | 71d | 2024-04-19 A | 2024-07-26 A | 1753 | 100% |  | 2024-04-19 | 2024-07-26 | 71d |  |  |  |  |  |  | Non-SIT LDSO, LDSO | Non-SIT LDSO, LDSO | Non-SIT LDSO Qualification |  | 5.24 | Ben Wickins | Complete | COMPLETE |  |  |  |  |  |
| 1803 | 1.5.8.2 | Test Plan Submission to MHHS Programme For Review | milestone | 0d | 2024-07-26 A | 2024-07-26 A | 1802 | 100% |  | 2024-07-26 | 2024-07-26 | 0d |  |  |  |  |  |  | LDSO | Non-SIT LDSO, LDSO | Non-SIT LDSO Qualification |  | 5.30 | Ben Wickins | Complete | COMPLETE | T3-QU-0114 | QAG (Non-SIT LDSO) |  |  |  |
| 1804 | 1.5.9 | **Test Environment** |  | 163d | 2024-04-17 A | 2024-11-29 |  | 53% | 76.22d | 2024-04-17 | 2024-11-29 | 111d | 2024-01-29 | 2024-07-05 | 78d |  |  | -0 | N/A | N/A | Non-SIT LDSO Qualification |  | 5.24 | N/A |  |  |  |  | Systems Integration Testing (SIT) |  |  |
| 1805 | 1.5.9.1 | Define Test Harness Requirements and Sign-Off with SRO |  | 13d | 2024-04-17 A | 2024-05-03 A | 514 | 100% |  | 2024-04-17 | 2024-05-03 | 13d |  |  |  |  |  |  | Non-SIT LDSO | Non-SIT LDSO,SRO,Sims and Ems | Non-SIT LDSO Qualification |  | 5.24 | Ben Wickins | Complete | COMPLETE |  |  |  |  |  |
| 1806 | 1.5.9.2 | Central System (DIP Env & Helix Test Harness) Test Environment DBT |  | 163d | 2024-04-17 A | 2024-11-29 | 514 | 82% | 29d | 2024-04-17 | 2024-11-29 | 92d |  |  | 78d | 0d | finish no earlier than 2024-11-29 |  | LDSO | Non SIT-LDSO, LDSO | Non-SIT LDSO Qualification |  | 5.24 | Ben Wickins | Green | GREEN |  |  |  |  |  |
| 1807 | 1.5.9.3 | Coordinate LDSO Environment Preparation |  | 101d | 2024-07-12 | 2024-11-29 | 1806FF |  |  | 2024-07-12 | 2024-11-29 | 30d |  |  | 78d | 0d |  |  | Non-SIT LDSO | Non-SIT LDSO | Non-SIT LDSO Qualification | -137.67 | 5.24 | Ben Wickins | Overdue Start | GREEN |  |  |  |  |  |
| 1808 | 1.5.9.4 | DIP available for Onboarding |  | 1d | 2024-08-01 A | 2024-08-01 A |  | 100% |  | 2024-08-01 | 2024-08-01 | 1d |  |  |  |  | start no earlier than 2024-08-01 |  | Test Env | Test Env, Non-SIT LDSO | Non-SIT LDSO Qualification |  | 5.24 | Ben Wickins | Complete | COMPLETE |  |  |  | 11/3: Ask Simon B for the link |  |
| 1809 | 1.5.9.5 | Qualification Testing for Non-SIT LDSOs Participants' environments) Ready to start DIP onboarding (incl. certificates and security compliance) | milestone | 0d | 2024-08-05 A | 2024-08-05 A | 1808FS+2d | 100% |  | 2024-08-05 | 2024-08-05 | 0d | 2024-04-26 | 2024-04-26 |  |  |  |  | Non-SIT LDSO | Code Bodies, PP, IPA | Non-SIT LDSO Qualification |  | 5.30 | Ben Wickins | Complete | COMPLETE | T3-QU-0009 | QAG (Non-SIT LDSO) | Systems Integration Testing (SIT) |  | T3 |
| 1810 | 1.5.9.6 | LDSO Test Environments Connection Confirmed to UIT Environment | milestone | 0d | 2024-11-29 | 2024-11-29 | 1809FS+32d, 1807 |  |  | 2024-11-29 | 2024-11-29 | 0d |  |  | 78d | 25d |  |  | Non-SIT LDSO | Code Bodies, PP, IPA | Non-SIT LDSO Qualification | 2.71 | 5.24 | Ben Wickins | Green | GREEN | T3-QU-0078 | QAG (Non-SIT LDSO) |  |  |  |
| 1811 | 1.5.10 | **Test Readiness** |  | 124d | 2024-07-02 A | 2024-12-20 |  | 64% | 44.64d | 2024-07-02 | 2024-12-20 | 76d |  |  | 784d |  |  | -0 | N/A | N/A | Non-SIT LDSO Qualification |  | 5.24 | N/A |  |  |  |  |  |  |  |
| 1812 | 1.5.10.1 | Preparation for Interim Test Readiness Report |  | 19d | 2024-07-02 A | 2024-07-26 A | 1786 | 100% |  | 2024-07-02 | 2024-07-26 | 30d |  |  |  |  |  |  | LDSO | LDSO, Non-SIT LDSO | Non-SIT LDSO Qualification |  | 5.24 | Ben Wickins | Complete | COMPLETE |  |  |  |  |  |
| 1813 | 1.5.10.2 | Interim Test Readiness Report Submission to MHHS Programme for Review | milestone | 0d | 2024-07-26 A | 2024-07-26 A | 1812 | 100% |  | 2024-07-26 | 2024-07-26 | 0d |  |  |  |  |  |  | LDSO | Non-SIT LDSO, LDSO | Non-SIT LDSO Qualification |  | 5.25 | Ben Wickins | Complete | COMPLETE | T3-QU-0116 | QAG (Non-SIT LDSO) |  |  |  |
| 1814 | 1.5.10.3 | LDSO Update Readiness Report & Final Assurance by Programme |  | 99d | 2024-07-29 A | 2024-12-12 | 1813 | 62% | 38d | 2024-07-29 | 2024-12-12 | 25d |  |  | 53d | 0d |  |  | Non-SIT LDSO, LDSO | Non-SIT LDSO, LDSO | Non-SIT LDSO Qualification |  | 5.24 | Ben Wickins | Green | GREEN |  |  |  |  |  |
| 1815 | 1.5.10.4 | Final Test Readiness Report Submitted to MHHS Programme |  | 1d | 2024-12-13 | 2024-12-13 | 1814 |  |  | 2024-12-13 | 2024-12-13 | 1d |  |  | 784d | 0d |  |  | LDSO | Non-SIT LDSO, Code Bodies | Non-SIT LDSO Qualification | 16.33 | 5.24 | Ben Wickins | Green | GREEN |  |  |  |  |  |
| 1816 | 1.5.10.5 | Final Programme Assurance of LDSO Test Readiness |  | 6d | 2024-12-13 | 2024-12-20 | 1814 |  |  | 2024-12-13 | 2024-12-20 | 21d |  |  | 53d | 0d |  |  | Non-SIT LDSO | Non-SIT LDSO, LDSO | Non-SIT LDSO Qualification | 16.33 | 5.24 | Ben Wickins | Green | GREEN |  |  |  |  |  |
| 1817 | 1.5.10.6 | Qualification Testing for Non-SIT LDSOs (Functional, Migration, NFT, Operational) Programme Test Readiness confirmed | milestone | 0d | 2024-12-20 | 2024-12-20 | 1815FS+5d, 1790, 1763, 1765, 1767, 1805 |  |  | 2024-12-20 | 2024-12-20 | 0d | 2024-07-05 | 2024-07-05 | 784d |  |  |  | Non-SIT LDSO | SI Test, PP, Non-SIT LDSO | Non-SIT LDSO Qualification | 23.71 | 5.24 | Ben Wickins | Green | RED | T3-QU-0007 | QAG (Non-SIT LDSO) | Systems Integration Testing (SIT) |  | T3 |
| 1818 | 1.5.10.7 | Qualification Testing for Non-SIT LDSOs (Functional, Migration, NFT, Operational) Test Readiness Confirmed (Final Test Readiness Review for LDSO) | milestone | 0d | 2024-12-20 | 2024-12-20 | 1814, 1816 |  |  | 2024-12-20 | 2024-12-20 | 0d | 2024-07-05 | 2024-07-05 | 53d | 0d |  |  | LDSO | SI Test, PP, LDSO | Non-SIT LDSO Qualification | 23.71 | 5.24 | Ben Wickins | Green | RED | T2-QU-0550 | QAG (Non-SIT LDSO) | Systems Integration Testing (SIT) |  |  |
| 1819 | 1.5.11 | **Test Window** |  | 165d? | 2025-01-06 | 2025-08-22 |  |  |  | 2025-01-06 | 2025-05-16 | 59d |  |  | 53d |  |  | -0 | N/A | N/A | Non-SIT LDSO Qualification | -527.67 | 6.0 | N/A |  |  |  | QAG |  |  |  |
| 1820 | 1.5.11.1 | **All Non-SIT LDSOs Qualification Testing** |  | 94d? | 2025-01-06 | 2025-05-16 | 1818, 1810 |  |  | 2025-01-06 | 2025-05-16 | 59d |  |  | 53d | 10d |  |  | LDSO | Non-SIT LDSO,Code Bodies, LDSO | Non-SIT LDSO Qualification | 118.33 | 6.0 | Ben Wickins |  |  |  | QAG |  |  |  |
| 1821 | 1.5.11.1.1 | Non-SIT LDSO QT Test Execution Starts | milestone | 0d | 2025-01-06 | 2025-01-06 | 1818FS+11d |  |  | 2025-01-06 | 2025-01-06 | 0d |  |  | 53d | 0d | start no earlier than 2024-11-01 |  | Non-SIT LDSO | Non-SIT LDSO, LDSO, Code Bodies | Non-SIT LDSO Qualification | 40.71 | 6.0 | Ben Wickins | Green | GREEN | T3-QU-0115 | QAG (Non-SIT LDSO) |  |  |  |
| 1822 | 1.5.11.1.2 | Non-SIT LDSO QT - Migration Testing |  | 20d? | 2025-01-06 | 2025-01-31 | 1821FS-1d |  |  | 2025-01-06 | 2025-01-31 | 0d |  |  | 53d | 0d |  |  | LDSO |  | Non-SIT LDSO Qualification | 40.33 | 6.0 | Ben Wickins | Green | GREEN | T3-QU-0125 | QAG |  |  |  |
| 1823 | 1.5.11.1.3 | Non-SIT LDSO QT - Functional Testing |  | 40d? | 2025-02-03 | 2025-03-28 | 1822 |  |  | 2025-02-03 | 2025-03-28 | 0d |  |  | 53d | 0d |  |  | LDSO |  | Non-SIT LDSO Qualification | 68.33 | 6.0 | Ben Wickins | Green | GREEN | T3-QU-0126 | QAG |  |  |  |
| 1824 | 1.5.11.1.4 | Non-SIT LDSO QT - Operational Testing |  | 15d? | 2025-03-31 | 2025-04-18 | 1823 |  |  | 2025-03-31 | 2025-04-18 | 0d |  |  | 664d | 0d |  |  | LDSO |  | Non-SIT LDSO Qualification | 124.33 | 6.0 | Ben Wickins | Green | GREEN | T3-QU-0127 | QAG |  |  |  |
| 1825 | 1.5.11.1.5 | Non-SIT LDSO QT - Non-Functional Testing |  | 15d? | 2025-04-21 | 2025-05-09 | 1824, 1791 |  |  | 2025-04-21 | 2025-05-09 | 0d |  |  | 664d |  |  |  | LDSO |  | Non-SIT LDSO Qualification | 145.33 | 6.0 | Ben Wickins | Green | GREEN | T3-QU-0128 | QAG |  |  |  |
| 1826 | 1.5.11.1.6 | Non-SIT LDSO QT - Regression Testing |  | 30d? | 2025-03-31 | 2025-05-09 | 1823 |  |  | 2025-03-31 | 2025-05-09 | 0d |  |  | 53d | 4d |  |  | LDSO |  | Non-SIT LDSO Qualification | 124.33 | 6.0 | Ben Wickins | Green | GREEN | T3-QU-0129 | QAG |  |  |  |
| 1827 | 1.5.11.1.7 | Qualification Testing for Non-SIT LDSOs (Functional, Migration, NFT, Operational) 1 End | milestone | 0d | 2025-05-16 | 2025-05-16 | 1826 |  |  | 2025-05-16 | 2025-05-16 | 0d |  |  | 49d | 0d | start no earlier than 2025-05-16 |  | LDSO |  | Non-SIT LDSO Qualification | 170.33 | 6.0 | Ben Wickins | Green | GREEN | T3-QU-0010 | QAG |  |  |  |
| 1828 | 1.5.11.2 | Potential for non-SIT LDSO QT Regression for Qualification |  | 70d? | 2025-05-19 | 2025-08-22 | 1827FS+1d |  |  | 2025-05-19 | 2025-08-22 | 0d |  |  | 609d |  |  |  | Non-SIT LDSO |  | Non-SIT LDSO Qualification | 173.33 | 6.12 | Ben Wickins | Green | GREEN |  | QAG (Non-SIT LDSO) |  |  |  |

Notes:
- 1800: Guidance: 18/7/24: Date change from 18/7/24 to 22/8/24 approved at QAG on 18/7/24
- 1814: 25/09/24 - End date amended to 20/12/24.
- 1817: 18/11/24 - Milestone RAG'd red because a predecssor activity (T3-QU-0076) is delayed because at least one participant is being delayed, but the factors behind this are internal to them, so not affecting all PPs.
- 1818: 18/11/24 - Milestone RAG'd red because a predecssor activity (T3-QU-0076) is delayed because at least one participant is being delayed, but the factors behind this are internal to them, so not affecting all PPs.
- 1821: 18/11/24 - Despite the fact the dependent activity (T3-QU-0076) has a red RAG status, this is still green. This is because T3-QU-0076 is going to miss the deadline is due to internal issues that affectl only a small number of PPs, which means the rest of PPs will start test execution on 06/01/25 as planned.
- 1828: 11/11/24 - New activity added for potential non-SIT LDSO QT Regression for Qualification. Programme to confirm scope and duration. This is because only two participants will miss the submission deadline due to internal issues to them.

| ID | WBS | Task | Type | Duration | Start | Finish | Predecessors | Complete | Remaining | Baseline start | Baseline finish | Baseline duration | Baseline 1 start | Baseline 1 finish | Total slack | Free slack | Constraint | Baseline cost | Responsible | Involved | Text9 | Update Version | MHHS Resource Name | Task Status | Sched Status | RAG | Milestone ID | Text29 | MHHS Programme Phase |
| --- | --- | --- | --- | --- | --- | --- | --- | --- | --- | --- | --- | --- | --- | --- | --- | --- | --- | --- | --- | --- | --- | --- | --- | --- | --- | --- | --- | --- | --- |
| 1829 | 1.5.12 | **Test Result Assurance** |  | 29d | 2025-04-21 | 2025-05-29 |  |  |  | 2025-04-21 | 2025-05-29 | 60d |  |  | 49d |  |  | -0 | N/A | N/A | Non-SIT LDSO Qualification | 6.0 | N/A |  |  |  |  |  |  |
| 1830 | 1.5.12.1 | LDSOs Develop & Submit Test Report (QT Test Completion Report) |  | 19d | 2025-04-21 | 2025-05-16 | 1827FF |  |  | 2025-04-21 | 2025-05-16 | 19d |  |  | 49d | 0d |  |  | LDSO | Non-SIT LDSO, LDSO | Non-SIT LDSO Qualification | 6.0 | Ben Wickins | 145.33 | Green | GREEN |  |  |  |
| 1831 | 1.5.12.2 | Test Reports Reviewed By MHHS & Code Bodies & Finalised |  | 10d | 2025-05-16 | 2025-05-29 | 1830 |  |  | 2025-05-16 | 2025-05-29 | 16d |  |  | 650d | 0d |  |  | Non-SIT LDSO | Non-SIT LDSO, Code Bodies | Non-SIT LDSO Qualification | 6.0 | Ben Wickins | 170.33 | Green | GREEN |  |  |  |
| 1832 | 1.5.12.3 | Non-SIT LDSOs submission deadline for their QT Test Completion Report to MHHS Programme | milestone | 0d | 2025-05-29 | 2025-05-29 | 1831, 1820 |  |  | 2025-05-29 | 2025-05-29 | 0d |  |  | 650d | 61d |  |  | Non-SIT LDSO | Non-SIT LDSO | Non-SIT LDSO Qualification | 6.0 | Ben Wickins | 183.71 | Green | GREEN | T3-QU-0079 | QAG (Non-SIT LDSO) |  |
| 1833 | 1.5.13 | **Non-SIT LDSO Qualification Closure** |  | 20d | 2025-08-25 | 2025-09-19 |  |  |  | 2025-05-30 | 2025-08-22 | 49d |  |  | 589d |  |  | -0 | N/A | N/A | Non-SIT LDSO Qualification | 6.0 | N/A |  |  |  |  |  |  |
| 1834 | 1.5.13.1 | Non-SIT LDSO Qualification Learned Captured |  | 15d | 2025-08-25 | 2025-09-12 | 1832, 1925 |  |  | 2025-05-30 | 2025-06-19 | 15d |  |  | 589d | 0d |  |  | Non-SIT LDSO | Non-SIT LDSO | Non-SIT LDSO Qualification | 6.0 | Ben Wickins | 271.33 | Red | RED |  |  |  |
| 1835 | 1.5.13.2 | Non-SIT LDSO Qualification Closure Down |  | 5d | 2025-09-15 | 2025-09-19 | 1834 |  |  | 2025-06-20 | 2025-06-26 | 5d |  |  | 589d |  |  |  | Non-SIT LDSO | Non-SIT LDSO | Non-SIT LDSO Qualification | 6.0 | Ben Wickins | 292.33 | Red | RED |  |  |  |
| 1836 | 1.6 | **S & A QUALIFICATION** |  | 843d? | 2023-11-07 A | 2027-01-28 |  | 48% | 438.89d? | 2023-11-07 | 2027-01-28 | 603d | 2024-01-29 | 2024-07-05 | 235d |  |  | -0 | N/A | N/A | S&A Qualification |  | N/A | -461.67 |  |  |  |  | Systems Integration Testing (SIT) |
| 1837 | 1.6.1 | **MHHS Qualification - Qualification Deliverables** |  | 463d | 2023-11-07 A | 2025-08-14 |  | 92% | 35.89d | 2023-11-07 | 2025-08-14 | 349d |  |  | 605d |  |  | -0 | N/A | N/A | S&A Qualification | 5.24 | N/A | -131.67 |  |  |  |  |  |
| 1838 | 1.6.1.1 | **BSC & REC Assessment Criteria** |  | 463d | 2023-11-07 A | 2025-08-14 A |  | 100% |  | 2023-11-07 | 2025-08-14 | 212d |  |  |  |  |  | -0 | N/A | N/A | S&A Qualification | 5.24 | N/A | -131.67 |  |  |  |  |  |
| 1839 | 1.6.1.1.1 | Draft BSC Assessment Criteria (Functional) |  | 21d | 2023-11-07 A | 2023-12-05 A |  | 100% |  | 2023-11-07 | 2023-12-05 | 21d |  |  |  |  | finish no earlier than 2023-12-05 |  | Code Bodies | Code Bodies | S&A Qualification | 5.24 | Laura Kennedy |  | Complete | COMPLETE |  |  |  |
| 1840 | 1.6.1.1.2 | BSC PAB Review |  | 1d | 2023-12-14 A | 2023-12-14 A |  | 100% |  | 2023-12-14 | 2023-12-14 | 1d |  |  |  |  | start no earlier than 2023-12-14 |  | Code Bodies | Code Bodies | S&A Qualification | 5.24 | Laura Kennedy |  | Complete | COMPLETE |  |  |  |
| 1841 | 1.6.1.1.3 | Update BSC Assessment Criteria (Functional, Non-Functional, Migration) |  | 30d | 2024-02-07 A | 2024-03-19 A |  | 100% |  | 2024-02-07 | 2024-03-19 | 30d |  |  |  |  | finish no earlier than 2024-03-19 |  | Code Bodies | Code Bodies | S&A Qualification | 5.24 | Laura Kennedy |  | Complete | COMPLETE |  |  |  |
| 1842 | 1.6.1.1.4 | REC & BSC PAB Approval |  | 3d | 2024-03-26 A | 2024-03-28 A |  | 100% |  | 2024-03-26 | 2024-03-28 | 3d |  |  |  |  | start no earlier than 2024-03-28 |  | Code Bodies | Code Bodies | S&A Qualification | 5.24 | Laura Kennedy |  | Complete | COMPLETE |  |  |  |
| 1843 | 1.6.1.1.5 | Update BSC Assessment Criteria (Functional, Non-Functional, Migration, Operational) |  | 20d | 2024-07-24 A | 2024-08-20 A |  | 100% |  | 2024-07-24 | 2024-08-20 | 20d |  |  |  |  |  |  | Code Bodies | Code Bodies | S&A Qualification | 5.24 | Laura Kennedy |  | Complete | COMPLETE |  |  |  |
| 1844 | 1.6.1.1.6 | Assessment Criteria (Functional, Non-Functional, Migration, Operational) Approved by REC PAB and BSC PAB |  | 250d | 2024-08-29 A | 2025-08-14 A | 1843FS+7d | 100% |  | 2024-08-29 | 2025-08-14 | 0d |  |  |  |  | start no earlier than 2023-09-15 |  | Code Bodies | Code Bodies | S&A Qualification | 5.25 | Laura Kennedy |  | Complete | COMPLETE | T3-QU-0080 | QAG |  |
| 1845 | 1.6.1.2 | **Qualification Approach and Plan** |  | 194d | 2023-12-04 A | 2024-08-29 A |  | 100% |  | 2023-12-04 | 2024-08-29 | 194d |  |  |  |  |  | -0 | N/A | N/A | S&A Qualification | 5.24 | N/A | -131.67 |  |  |  |  |  |
| 1846 | 1.6.1.2.1 | **Qualification Approach and Plan v2** |  | 84d | 2023-12-04 A | 2024-03-28 A |  | 100% |  | 2023-12-04 | 2024-03-28 | 84d |  |  |  |  |  | -0 | N/A | N/A | S&A Qualification | 5.24 | N/A | -131.67 |  |  |  |  |  |
| 1847 | 1.6.1.2.1.1 | Draft Qualification Approach and Plan v2 |  | 30d | 2023-12-04 A | 2024-01-12 A |  | 100% |  | 2023-12-04 | 2024-01-12 | 30d |  |  |  |  | finish no earlier than 2024-01-12 |  | Code Bodies | Code Bodies | S&A Qualification | 5.24 | Laura Kennedy |  | Complete | COMPLETE |  |  |  |
| 1848 | 1.6.1.2.1.2 | Internal Review (Code Bodies and MHHSP) for Qualification Approach and Plan V2 |  | 10d | 2024-01-15 A | 2024-01-26 A | 1847 | 100% |  | 2024-01-15 | 2024-01-26 | 10d |  |  |  |  | finish no earlier than 2024-01-26 |  | Code Bodies, SI Team, SRO | Code Bodies, SI Team, SRO | S&A Qualification | 5.24 | Laura Kennedy |  | Complete | COMPLETE |  |  |  |
| 1849 | 1.6.1.2.1.3 | Industry consultation for Qualification Approach and Plan v2 |  | 11d | 2024-01-31 A | 2024-02-14 A | 1848 | 100% |  | 2024-01-31 | 2024-02-14 | 11d |  |  |  |  | start no earlier than 2024-01-31 |  | Participants | Participants | S&A Qualification | 5.24 | Laura Kennedy |  | Complete | COMPLETE |  |  |  |
| 1850 | 1.6.1.2.1.4 | Update Qualification Approach and Plan v2 post industry consultation |  | 10d | 2024-02-15 A | 2024-02-28 A | 1849 | 100% |  | 2024-02-15 | 2024-02-28 | 10d |  |  |  |  |  |  | Code Bodies | Code Bodies | S&A Qualification | 5.24 | Laura Kennedy |  | Complete | COMPLETE |  |  |  |
| 1851 | 1.6.1.2.1.5 | QWG Endorsement of Qualification Approach and Plan v2 |  | 1d | 2024-03-12 A | 2024-03-12 A |  | 100% |  | 2024-03-12 | 2024-03-12 | 1d |  |  |  |  | start no earlier than 2024-03-12 |  | Code Bodies | Code Bodies | S&A Qualification | 5.24 | Laura Kennedy |  | Complete | COMPLETE |  |  |  |
| 1852 | 1.6.1.2.1.6 | QAG Approval of Qualification Approach and Plan v2 |  | 1d | 2024-03-21 A | 2024-03-21 A |  | 100% |  | 2024-03-21 | 2024-03-21 | 1d |  |  |  |  | start no earlier than 2024-03-21 |  | Code Bodies | Code Bodies | S&A Qualification | 5.24 | Laura Kennedy |  | Complete | COMPLETE |  |  |  |
| 1853 | 1.6.1.2.1.7 | BSC and REC PAB Approval of Qualification Approach and Plan v2 |  | 3d | 2024-03-26 A | 2024-03-28 A |  | 100% |  | 2024-03-26 | 2024-03-28 | 3d |  |  |  |  | finish no earlier than 2024-03-28 |  | Code Bodies | Code Bodies | S&A Qualification | 5.24 | Laura Kennedy |  | Complete | COMPLETE |  |  |  |
| 1854 | 1.6.1.2.1.8 | Functional Testing elements of Qualification Approach & Plan v2 approvement by REC PAB and BSC PAB | milestone | 0d | 2024-03-28 A | 2024-03-28 A | 1853 | 100% |  | 2024-03-28 | 2024-03-28 | 0d |  |  |  |  |  |  | Code Bodies | Code Bodies | S&A Qualification | 5.24 | Laura Kennedy |  | Complete | COMPLETE | T3-QU-0063 | QAG |  |
| 1855 | 1.6.1.2.1.9 | Migration Testing elements of Qualification Approach & Plan v2 appoved by REC PAB and BSC PAB | milestone | 0d | 2024-03-28 A | 2024-03-28 A | 1853 | 100% |  | 2024-03-28 | 2024-03-28 | 0d |  |  |  |  |  |  | Code Bodies | Code Bodies | S&A Qualification | 5.24 | Laura Kennedy |  | Complete | COMPLETE | T3-QU-0064 | QAG |  |

Notes:
- 1844: Assessment criteria is going to PAB for approval on 26/09/24, expected to be complete

| ID | WBS | Task | Type | Duration | Start | Finish | Predecessors | Complete | Remaining | Baseline start | Baseline finish | Baseline duration | Total slack | Constraint | Baseline cost | Responsible | Involved | Text9 | Task Status | Update Version | MHHS Resource Name | Sched Status | RAG | Milestone ID | Text29 |
| --- | --- | --- | --- | --- | --- | --- | --- | --- | --- | --- | --- | --- | --- | --- | --- | --- | --- | --- | --- | --- | --- | --- | --- | --- | --- |
| 1856 | 1.6.1.2.2 | **Qualification Approach and Plan v3** |  | 84d | 2024-05-06 A | 2024-08-29 A |  | 100% |  | 2024-05-06 | 2024-08-29 | 84d |  |  | -0 | N/A | N/A | S&A Qualification | -133.67 | 5.24 | N/A |  |  |  |  |
| 1857 | 1.6.1.2.2.1 | Draft Qualification Approach and Plan v3 |  | 35d | 2024-05-06 A | 2024-06-21 A | 1067 | 100% |  | 2024-05-06 | 2024-06-21 | 35d |  | finish no earlier than 2024-05-17 |  | Code Bodies | Code Bodies | S&A Qualification |  | 5.27 | Laura Kennedy | Complete | COMPLETE |  |  |
| 1858 | 1.6.1.2.2.2 | Internal Review (Code Bodies and MHHSP) of Qualification Approach and Plan v3 |  | 10d | 2024-06-24 A | 2024-07-05 A | 1857 | 100% |  | 2024-06-24 | 2024-07-05 | 10d |  |  |  | Code Bodies, SI Team, SRO | Code Bodies, SI Team, SRO | S&A Qualification |  | 5.27 | Laura Kennedy | Complete | COMPLETE |  |  |
| 1859 | 1.6.1.2.2.3 | Industry consultation for Qualification Approach and Plan v3 |  | 10d | 2024-07-08 A | 2024-07-19 A | 1858 | 100% |  | 2024-07-08 | 2024-07-19 | 10d |  |  |  | Participants | Participants | S&A Qualification |  | 5.27 | Laura Kennedy | Complete | COMPLETE |  |  |
| 1860 | 1.6.1.2.2.4 | Update Qualification Approach and Plan v3 Post-Consultation |  | 10d | 2024-07-22 A | 2024-08-02 A | 1859 | 100% |  | 2024-07-22 | 2024-08-02 | 10d |  |  |  | Code Bodies | Code Bodies | S&A Qualification |  | 5.27 | Laura Kennedy | Complete | COMPLETE |  |  |
| 1861 | 1.6.1.2.2.5 | QWG Endorsement of Qualification Approach and Plan v3 |  | 1d | 2024-08-13 A | 2024-08-13 A | 1860FS+6d | 100% |  | 2024-08-13 | 2024-08-13 | 1d |  |  |  | Code Bodies | Code Bodies | S&A Qualification |  | 5.27 | Laura Kennedy | Complete | COMPLETE |  |  |
| 1862 | 1.6.1.2.2.6 | QAG Approval of Qualification Approach and Plan v3 | milestone | 0d | 2024-08-22 A | 2024-08-22 A | 1861FS+7d | 100% |  | 2024-08-22 | 2024-08-22 | 0d |  |  |  | Code Bodies | Code Bodies | S&A Qualification |  | 5.27 | Laura Kennedy | Complete | COMPLETE | T3-QU-0081 | QAG |
| 1863 | 1.6.1.2.2.7 | BSC and REC PAB Approval of Qualification Approach and Plan v3 |  | 3d | 2024-08-27 A | 2024-08-29 A | 1862FS+2d | 100% |  | 2024-08-27 | 2024-08-29 | 3d |  |  |  | Code Bodies | Code Bodies | S&A Qualification |  | 5.27 | Laura Kennedy | Complete | COMPLETE |  |  |
| 1864 | 1.6.1.2.2.8 | Non-Functional Testing elements of Qualification Approach and Plan v3 approved by REC PAB and BSC PAB | milestone | 0d | 2024-08-29 A | 2024-08-29 A | 1863 | 100% |  | 2024-08-29 | 2024-08-29 | 0d |  |  |  | Code Bodies | Code Bodies | S&A Qualification |  | 5.27 | Laura Kennedy | Complete | COMPLETE | T3-QU-0065 | QAG |
| 1865 | 1.6.1.3 | **Qualification Assessment Document** |  | 346d | 2023-12-22 A | 2025-04-18 |  | 81% | 66.11d | 2023-12-22 | 2025-03-07 | 316d | 689d |  | -0 | N/A | N/A | S&A Qualification | -131.67 | 5.24 | N/A |  |  |  |  |
| 1866 | 1.6.1.3.1 | **Qualification Assessment Document v1** |  | 70d | 2023-12-22 A | 2024-03-28 A |  | 100% |  | 2023-12-22 | 2024-03-28 | 70d |  |  | -0 | N/A | N/A | S&A Qualification | -131.67 | 5.24 | N/A |  |  |  |  |
| 1867 | 1.6.1.3.1.1 | Draft Qualification Assessment Document v1 |  | 30d | 2023-12-22 A | 2024-02-01 A |  | 100% |  | 2023-12-22 | 2024-02-01 | 30d |  | finish no earlier than 2024-02-01 |  | Code Bodies | Code Bodies | S&A Qualification |  | 5.24 | Laura Kennedy | Complete | COMPLETE |  |  |
| 1868 | 1.6.1.3.1.2 | Internal Review (Code Bodies and MHHSP) of Qualification Assessment Document v1 |  | 10d | 2024-02-01 A | 2024-02-14 A |  | 100% |  | 2024-02-01 | 2024-02-14 | 10d |  | finish no earlier than 2024-02-14 |  | Code Bodies, SI Team, SRO | Code Bodies, SI Team, SRO | S&A Qualification |  | 5.24 | Laura Kennedy | Complete | COMPLETE |  |  |
| 1869 | 1.6.1.3.1.3 | Industry consultation for Qualification Assessment Document v1 |  | 11d | 2024-02-16 A | 2024-03-01 A |  | 100% |  | 2024-02-16 | 2024-03-01 | 11d |  | start no earlier than 2024-02-16 |  | Participants | Participants | S&A Qualification |  | 5.24 | Laura Kennedy | Complete | COMPLETE |  |  |
| 1870 | 1.6.1.3.1.4 | Update Post-Consultation for Qualification Assessment Document v1 |  | 10d | 2024-03-04 A | 2024-03-15 A | 1869 | 100% |  | 2024-03-04 | 2024-03-15 | 10d |  |  |  | Code Bodies | Code Bodies | S&A Qualification |  | 5.24 | Laura Kennedy | Complete | COMPLETE |  |  |
| 1871 | 1.6.1.3.1.5 | BSC and REC PAB Approval of Qualification Assessment Document v1 |  | 3d | 2024-03-26 A | 2024-03-28 A |  | 100% |  | 2024-03-26 | 2024-03-28 | 3d |  | start no earlier than 2024-03-26 |  | Code Bodies | Code Bodies | S&A Qualification |  | 5.24 | Laura Kennedy | Complete | COMPLETE |  |  |
| 1872 | 1.6.1.3.1.6 | Qualification Assessment Document v1 approved by REC PAB and BSC PAB | milestone | 0d | 2024-03-28 A | 2024-03-28 A | 1871 | 100% |  | 2024-03-28 | 2024-03-28 | 0d |  |  |  | Code Bodies | Code Bodies | S&A Qualification |  | 5.24 | Laura Kennedy | Complete | COMPLETE | T3-QU-0066 | QAG |
| 1873 | 1.6.1.3.2 | **Qualification Assessment Document v3** |  | 110d | 2024-03-29 A | 2024-08-29 A |  | 100% |  | 2024-03-29 | 2024-08-29 | 110d |  |  | -0 | N/A | N/A | S&A Qualification | -131.67 | 5.24 | N/A |  |  |  |  |
| 1874 | 1.6.1.3.2.1 | Draft Qualification Assessment Document V1.1 |  | 26d | 2024-03-29 A | 2024-05-03 A | 1872 | 100% |  | 2024-03-29 | 2024-05-03 | 26d |  |  |  |  |  | S&A Qualification |  | 5.24 | Laura Kennedy | Complete | COMPLETE |  |  |
| 1875 | 1.6.1.3.2.2 | Industry Consultation for Qualification Assessment Document V1.1 |  | 12d | 2024-05-06 A | 2024-05-21 A | 1874 | 100% |  | 2024-05-06 | 2024-05-21 | 12d |  |  |  |  |  | S&A Qualification |  | 5.24 | Laura Kennedy | Complete | COMPLETE |  |  |
| 1876 | 1.6.1.3.2.3 | Draft Qualification Assessment Document v3 |  | 6d | 2024-06-14 A | 2024-06-21 A | 1178, 1875 | 100% |  | 2024-06-14 | 2024-06-21 | 6d |  |  |  | Code Bodies | Code Bodies | S&A Qualification |  | 5.24 | Laura Kennedy | Complete | COMPLETE |  |  |
| 1877 | 1.6.1.3.2.4 | Internal Review (Code Bodies and MHHSP) of Qualification Assessment Document v3 |  | 10d | 2024-06-24 A | 2024-07-05 A | 1876 | 100% |  | 2024-06-24 | 2024-07-05 | 10d |  |  |  | Code Bodies, SI Team, SRO | Code Bodies, SI Team, SRO | S&A Qualification |  | 5.24 | Laura Kennedy | Complete | COMPLETE |  |  |
| 1878 | 1.6.1.3.2.5 | Industry consultation for Qualification Assessment Document v3 |  | 10d | 2024-07-08 A | 2024-07-19 A | 1877 | 100% |  | 2024-07-08 | 2024-07-19 | 10d |  |  |  | Participants | Participants | S&A Qualification |  | 5.24 | Laura Kennedy | Complete | COMPLETE |  |  |
| 1879 | 1.6.1.3.2.6 | Update Post-Consultation for Qualification Assessment Document v3 |  | 10d | 2024-07-22 A | 2024-08-02 A | 1878 | 100% |  | 2024-07-22 | 2024-08-02 | 10d |  |  |  | Code Bodies | Code Bodies | S&A Qualification |  | 5.24 | Laura Kennedy | Complete | COMPLETE |  |  |
| 1880 | 1.6.1.3.2.7 | QWG Endorsement of Qualification Assessment Document v3 |  | 1d | 2024-08-13 A | 2024-08-13 A | 1879FS+6d | 100% |  | 2024-08-13 | 2024-08-13 | 1d |  |  |  | Code Bodies | Code Bodies | S&A Qualification |  | 5.24 | Laura Kennedy | Complete | COMPLETE |  |  |
| 1881 | 1.6.1.3.2.8 | QAG Endorsement of Qualification Assessment Document v3 |  | 1d | 2024-08-22 A | 2024-08-22 A | 1880FS+6d | 100% |  | 2024-08-22 | 2024-08-22 | 1d |  |  |  | Code Bodies | Code Bodies | S&A Qualification |  | 5.25 | Laura Kennedy | Complete | COMPLETE | T3-QU-0083 | QAG |
| 1882 | 1.6.1.3.2.9 | BSC and REC PAB Approval of Qualification Assessment Document v3 |  | 3d | 2024-08-27 A | 2024-08-29 A | 1881FS+2d | 100% |  | 2024-08-27 | 2024-08-29 | 3d |  |  |  | Code Bodies | Code Bodies | S&A Qualification |  | 5.24 | Laura Kennedy | Complete | COMPLETE |  |  |
| 1883 | 1.6.1.3.2.10 | Qualification Assessment Document v3 approved by REC PAB and BSC PAB | milestone | 0d | 2024-08-29 A | 2024-08-29 A | 1882 | 100% |  | 2024-08-29 | 2024-08-29 | 0d |  |  |  | Code Bodies | Code Bodies | S&A Qualification |  | 5.24 | Laura Kennedy | Complete | COMPLETE | T3-QU-0067 | QAG |

Notes:
- 1862: Approved at QAG on 22/08/24.
- 1881: Approved at QAG on 22/08/24.

| ID | WBS | Task | Type | Duration | Start | Finish | Predecessors | Complete | Remaining | Baseline start | Baseline finish | Baseline duration | Baseline 1 start | Baseline 1 finish | Total slack | Free slack | Constraint | Baseline cost | Responsible | Involved | Text9 | Task Status | Update Version | MHHS Resource Name | Sched Status | RAG | Milestone ID | Text29 | MHHS Programme Phase |
| --- | --- | --- | --- | --- | --- | --- | --- | --- | --- | --- | --- | --- | --- | --- | --- | --- | --- | --- | --- | --- | --- | --- | --- | --- | --- | --- | --- | --- | --- |
| 1884 | 1.6.1.3.3 | **Qualification Assessment Document Portal** |  | 315d | 2024-02-05 A | 2025-04-18 |  | 65% | 110.53d | 2024-02-05 | 2025-03-07 | 285d |  |  | 689d |  |  | -0 | N/A | N/A | S&A Qualification | -131.67 | 5.24 | N/A |  |  |  |  |  |
| 1885 | 1.6.1.3.3.1 | Design Completion |  | 30d | 2024-02-05 A | 2024-03-15 A |  | 100% |  | 2024-02-05 | 2024-03-15 | 30d |  |  |  |  | finish no earlier than 2024-03-15 |  | QAD Portal Dev Team | QAD Portal Dev Team | S&A Qualification |  | 5.24 | Laura Kennedy | Complete | COMPLETE |  |  |  |
| 1886 | 1.6.1.3.3.2 | Qualification Assessment Document Portal Build |  | 30d | 2024-03-18 A | 2024-04-26 A | 1885 | 100% |  | 2024-03-18 | 2024-04-26 | 30d |  |  |  |  |  |  | QAD Portal Dev Team | QAD Portal Dev Team | S&A Qualification |  | 5.24 | Laura Kennedy | Complete | COMPLETE |  |  |  |
| 1887 | 1.6.1.3.3.3 | Qualification Assessment Document Internal Testing |  | 20d | 2024-04-29 A | 2024-05-24 A | 1886 | 100% |  | 2024-04-29 | 2024-05-24 | 20d |  |  |  |  |  |  | QAD Portal Dev Team. Code Bodies | QAD Portal Dev Team. Code Bodies | S&A Qualification |  | 5.24 | Laura Kennedy | Complete | COMPLETE |  |  |  |
| 1888 | 1.6.1.3.3.4 | Qualification Assessment Document Portal Training and Onboarding Material Creation |  | 20d | 2024-05-27 A | 2024-06-21 A | 1887 | 100% |  | 2024-05-27 | 2024-06-21 | 20d |  |  |  |  |  |  | QAD Portal Dev Team | QAD Portal Dev Team | S&A Qualification |  | 5.24 | Laura Kennedy | Complete | COMPLETE |  |  |  |
| 1889 | 1.6.1.3.3.5 | Qualification Assessment Document Portal Webinar (Date TBC) |  | 1d | 2024-06-18 A | 2024-06-18 A |  | 100% |  | 2024-06-18 | 2024-06-18 | 1d |  |  |  |  | start no earlier than 2024-06-18 |  | QAD Portal Dev Team | QAD Portal Dev Team | S&A Qualification |  | 5.24 | Laura Kennedy | Complete | COMPLETE |  |  |  |
| 1890 | 1.6.1.3.3.6 | SIT Participant QAD Application Creation in Portal |  | 10d | 2024-12-09 | 2024-12-20 | 1888FS+120d |  |  | 2024-12-09 | 2024-12-20 | 10d |  |  | 774d | 0d |  |  | Code Bodies | Code Bodies | S&A Qualification | 12.33 | 5.24 | Laura Kennedy | Green | GREEN |  |  |  |
| 1891 | 1.6.1.3.3.7 | Non-SIT LDSO Participant QAD Application Creation in Portal |  | 10d | 2024-12-09 | 2024-12-20 | 1888FS+120d |  |  | 2024-12-09 | 2024-12-20 | 10d |  |  | 773d | 0d |  |  | Code Bodies | Code Bodies | S&A Qualification | 12.33 | 5.24 | Laura Kennedy | Green | GREEN |  |  |  |
| 1892 | 1.6.1.3.3.8 | QT Wave 1 Participant QAD Application Creation in Portal |  | 10d | 2025-04-07 | 2025-04-18 | 1888FS+205d |  |  | 2025-04-07 | 2025-04-18 | 10d |  |  | 6d | 0d |  |  | Code Bodies | Code Bodies | S&A Qualification | 131.33 | 6.1 | Laura Kennedy | Green | GREEN |  |  |  |
| 1893 | 1.6.1.3.3.9 | QT Wave 2 Participant QAD Application Creation in Portal |  | 10d | 2024-10-28 | 2024-11-08 | 1888FS+90d |  |  | 2024-10-28 | 2024-11-08 | 10d |  |  | 5d | 0d |  |  | Code Bodies | Code Bodies | S&A Qualification | -29.67 | 6.1 | Laura Kennedy | Green | GREEN |  |  |  |
| 1894 | 1.6.1.3.3.10 | QT Wave 3 Participant QAD Application Creation in Portal |  | 10d | 2024-12-30 | 2025-01-10 | 1888FS+135d |  |  | 2024-12-30 | 2025-01-10 | 10d |  |  | 9d | 0d |  |  | Code Bodies | Code Bodies | S&A Qualification | 33.33 | 6.1 | Laura Kennedy | Green | GREEN |  |  |  |
| 1895 | 1.6.1.3.3.11 | QT Wave 4 Participant QAD Application Creation in Portal |  | 10d | 2025-02-24 | 2025-03-07 | 1888FS+175d |  |  | 2025-02-24 | 2025-03-07 | 10d |  |  | 0d |  |  |  | Code Bodies | Code Bodies | S&A Qualification | 89.33 | 6.1 | Laura Kennedy | Green | GREEN |  |  |  |
| 1896 | 1.6.1.3.3.12 | Update to Qualification Assessment Document Portal post QAD V3 |  | 10d | 2024-08-30 A | 2024-09-12 A | 1883 | 100% |  | 2024-08-30 | 2024-09-12 | 10d |  |  |  |  |  |  | QAD Portal Dev Team | QAD Portal Dev Team | S&A Qualification |  | 6.1 | Laura Kennedy | Complete | COMPLETE |  |  |  |
| 1897 | 1.6.1.3.3.13 | Update to Qualification Assessment Document Portal post QAD V3 Complete | milestone | 0d | 2024-09-12 A | 2024-09-12 A | 1896 | 100% |  | 2024-09-12 | 2024-09-12 | 0d |  |  |  |  |  |  | QAD Portal Dev Team | QAD Portal Dev Team | S&A Qualification |  | 6.1 | Laura Kennedy | Complete | COMPLETE | T3-QU-0084 | QAG |  |
| 1898 | 1.6.2 | **MHHS Qualification - SIT Participants** |  | 249d | 2025-01-06 | 2025-12-18 |  |  |  | 2025-01-06 | 2025-12-22 | 194d | 2024-01-29 | 2024-07-05 | 61d |  |  | -0 | N/A | N/A | S&A Qualification | -133.67 | 6.11 | N/A |  |  |  |  | Systems Integration Testing (SIT) |
| 1899 | 1.6.2.1 | Initial QAD Submission Window opens | milestone | 0d | 2025-01-06 | 2025-01-06 | 1890FS+10d |  |  | 2025-01-06 | 2025-01-06 | 0d |  |  | 774d |  | start no earlier than 2025-01-06 |  | Participants | Participants | S&A Qualification | 40.33 | 6.11 | Laura Kennedy | Green | GREEN |  |  |  |
| 1900 | 1.6.2.2 | SIT Participants submit Initial QAD |  | 30d | 2025-01-06 | 2025-02-14 |  |  |  | 2025-01-06 | 2025-02-14 | 29d |  |  | 61d | 0d | start no earlier than 2025-01-06 |  | Participants | Participants | S&A Qualification | 40.33 | 6.11 | Laura Kennedy | Green | GREEN |  |  |  |
| 1901 | 1.6.2.3 | Code Bodies review Initial QAD |  | 36d | 2025-02-14 | 2025-04-04 | 1900FS-1d |  |  | 2025-02-14 | 2025-04-04 | 36d |  |  | 61d | 0d |  |  | Code Bodies | Code Bodies | S&A Qualification | 79.33 | 6.11 | Laura Kennedy | Green | GREEN |  |  |  |
| 1902 | 1.6.2.4 | Completion of Code Bodies review of Initial QAD | milestone | 0d | 2025-04-04 | 2025-04-04 | 1901 |  |  | 2025-04-04 | 2025-04-04 | 0d |  |  | 61d | 0d |  |  | Code Bodies | Code Bodies | S&A Qualification | 128.71 | 6.11 | Laura Kennedy | Green | GREEN |  |  |  |
| 1903 | 1.6.2.5 | **MHHS Qualification - SIT MVC Participants** |  | 113d | 2025-04-07 | 2025-09-10 |  |  |  | 2025-04-07 | 2025-09-11 | 64d |  |  | 6d |  |  |  | N/A | N/A | S&A Qualification | -154.67 | 6.11 | N/A |  |  |  |  |  |
| 1904 | 1.6.2.5.1 | Final QAD Submission Window (MVC) opens | milestone | 0d | 2025-04-07 | 2025-04-07 | 1901, 1897, 1902FS+1d |  |  | 2025-04-07 | 2025-04-07 | 0d |  |  | 61d | 0d |  |  | Participants | Participants | S&A Qualification | 131.71 | 6.11 | Laura Kennedy | Green | GREEN |  |  |  |
| 1905 | 1.6.2.5.2 | SIT MVC Participants submit Final QAD (exc Test Reports) |  | 25d | 2025-04-07 | 2025-05-09 | 1904FS-1d |  |  | 2025-04-07 | 2025-05-09 | 26d |  |  | 61d | 0d |  |  | Participants | Participants | S&A Qualification | 131.33 | 6.11 | Laura Kennedy | Green | GREEN |  |  |  |
| 1906 | 1.6.2.5.3 | Completion of Code Bodies review of Final QAD (MVC) |  | 20d | 2025-05-12 | 2025-06-06 | 1905, 1566FF |  |  | 2025-05-12 | 2025-06-06 | 19d |  |  | 61d | 55d |  |  | Code Bodies | Code Bodies | S&A Qualification | 166.33 | 6.11 | Laura Kennedy | Green | GREEN |  |  |  |
| 1907 | 1.6.2.5.4 | QAD Sign Off Deadline (MVC) + Test Reports | milestone | 0d | 2025-08-22 | 2025-08-22 | 1575, 1906 |  |  | 2025-08-22 | 2025-08-22 | 1d |  |  | 6d | 0d | start no earlier than 2025-07-11 |  | Participants | Participants | S&A Qualification | 268.71 | 6.11 | Laura Kennedy | Green | GREEN |  |  |  |
| 1908 | 1.6.2.5.5 | REC Code Manager / BSC PAB Approval of Qualification (MVC) | milestone | 0d | 2025-09-10 | 2025-09-10 | 1907FS+13d |  |  | 2025-09-11 | 2025-09-11 | 0d |  |  | 6d | 0d |  |  | Code Bodies | Code Bodies | S&A Qualification | 287.71 | 6.11 | Laura Kennedy | Green | GREEN | T3-QU-0085 | QAG |  |

Notes:
- 1890: 25/09/24 - These should move to start a week before the QAD window.
- 1891: 25/09/24 - These should move to start a week before the QAD window.
- 1892: 25/09/24 - These should move to start a week before the QAD window.
- 1893: 25/09/24 - Proposed that this is removed and replaced with a milestone for Batch 3 of Functional Tests, but this has not yet been confirmed.
- 1899: 25/09/24 - Forecast has moved to 06/01/25, this will be baseliend once CR55 is approved.
- 1900: 25/09/24 - Forecast has moved to 13/02/25, this will be baseliend once CR55 is approved.
- 1901: 25/09/24 - Forecast has moved to 04/04/25, this will be baseliend once CR55 is approved.
- 1902: 25/09/24 - Forecast has moved to 04/04/25, this will be baseliend once CR55 is approved.
- 1904: 25/09/24 - Forecast has moved to 04/04/25, this will be baseliend once CR55 is approved.

| ID | WBS | Task | Type | Duration | Start | Finish | Predecessors | Complete | Remaining | Baseline start | Baseline finish | Baseline duration | Total slack | Free slack | Constraint | Baseline cost | Responsible | Involved | Text9 | Task Status | Update Version | MHHS Resource Name | Sched Status | RAG | Milestone ID | Text29 |
| --- | --- | --- | --- | --- | --- | --- | --- | --- | --- | --- | --- | --- | --- | --- | --- | --- | --- | --- | --- | --- | --- | --- | --- | --- | --- | --- |
| 1909 | 1.6.2.6 | **MHHS Qualification - SIT Non-MVC Participants** |  | 154d | 2025-05-19 | 2025-12-18 |  |  |  | 2025-05-19 | 2025-12-22 | 129d | 29d |  |  |  | N/A | N/A | S&A Qualification | -154.67 | 6.11 | N/A |  |  |  |  |
| 1910 | 1.6.2.6.1 | Final QAD Submission Window (Non-MVC) opens | milestone | 0d | 2025-05-19 | 2025-05-19 | 1902FS+31d |  |  | 2025-05-19 | 2025-05-19 | 0d | 138d | 0d |  |  | Participants | Participants | S&A Qualification | 173.71 | 6.11 | Laura Kennedy | Green | GREEN |  |  |
| 1911 | 1.6.2.6.2 | SIT Non-MVC Participants submit Final QAD |  | 90d | 2025-05-19 | 2025-09-19 | 1910SS-1d |  |  | 2025-05-19 | 2025-09-19 | 86d | 49d | 0d |  |  | Participants | Participants | S&A Qualification | 173.33 | 6.11 | Laura Kennedy | Green | GREEN |  |  |
| 1912 | 1.6.2.6.3 | Completion of Code Bodies review of Final QAD (Non-MVC) |  | 25d | 2025-09-22 | 2025-10-24 | 1911 |  |  | 2025-09-22 | 2025-10-24 | 19d | 49d | 20d |  |  | Code Bodies | Code Bodies | S&A Qualification | 299.33 | 6.11 | Laura Kennedy | Green | GREEN |  |  |
| 1913 | 1.6.2.6.4 | QAD Sign Off Deadline (Non-MVC) |  | 1d | 2025-11-28 | 2025-11-28 | 1912FS+4d, 1597 |  |  | 2025-11-28 | 2025-11-28 | 1d | 29d | 0d |  |  | Participants | Participants | S&A Qualification | 366.33 | 6.11 | Laura Kennedy | Green | GREEN |  |  |
| 1914 | 1.6.2.6.5 | REC Code Manager / BSC PAB Approval of Qualification (Non-MVC) | milestone | 0d | 2025-12-18 | 2025-12-18 | 1913FS+14d |  |  | 2025-12-22 | 2025-12-22 | 0d | 29d | 0d |  |  | Code Bodies | Code Bodies | S&A Qualification | 386.71 | 6.11 | Laura Kennedy | Green | GREEN | T3-QU-0086 | QAG |
| 1915 | 1.6.3 | **MHHS Qualification - Non-SIT LDSO** |  | 178d | 2025-01-06 | 2025-09-10 |  |  |  | 2025-01-06 | 2025-09-11 | 115d | 58d |  |  | -0 | N/A | N/A | S&A Qualification | -133.67 | 6.11 | N/A |  |  |  |  |
| 1916 | 1.6.3.1 | Initial QAD Submission window opens | milestone | 0d | 2025-01-06 | 2025-01-06 | 1891FS+11d |  |  | 2025-01-06 | 2025-01-06 | 0d | 773d |  |  |  | Participants | Participants | S&A Qualification | 40.71 | 6.11 | Laura Kennedy | Green | GREEN |  |  |
| 1917 | 1.6.3.2 | Non-SIT LDSO Participants submit initial QAD |  | 30d | 2025-01-06 | 2025-02-14 |  |  |  | 2025-01-06 | 2025-02-14 | 29d | 58d | 0d | start no earlier than 2025-01-06 |  | Participants | Participants | S&A Qualification | 40.33 | 6.11 | Laura Kennedy | Green | GREEN |  |  |
| 1918 | 1.6.3.3 | Non-SIT LDSO QT Participants have submitted their initial QAD | milestone | 0d | 2025-02-14 | 2025-02-14 | 1917 |  |  | 2025-02-14 | 2025-02-14 | 0d | 58d | 0d |  |  | Participants | Participants | S&A Qualification | 79.71 | 6.11 | Laura Kennedy | Green | GREEN | T3-QU-0087 | QAG |
| 1919 | 1.6.3.4 | Code Bodies review of Non-SIT LDSO participants Initial QAD |  | 35d | 2025-02-17 | 2025-04-04 | 1918 |  |  | 2025-02-17 | 2025-04-04 | 36d | 58d | 0d |  |  | Code Bodies | Code Bodies | S&A Qualification | 82.33 | 6.11 | Laura Kennedy | Green | GREEN |  |  |
| 1920 | 1.6.3.5 | Completion of Code Bodies review of Initial QAD | milestone | 0d | 2025-04-04 | 2025-04-04 | 1919 |  |  | 2025-04-04 | 2025-04-04 | 0d | 58d | 0d |  |  | Code Bodies | Code Bodies | S&A Qualification | 128.71 | 6.11 | Laura Kennedy | Green | GREEN |  |  |
| 1921 | 1.6.3.6 | Final QAD Submission window opens | milestone | 0d | 2025-04-07 | 2025-04-07 | 1920FS+1d |  |  | 2025-04-07 | 2025-04-07 | 0d | 58d | 9d |  |  | Participants | Participants | S&A Qualification | 131.71 | 6.11 | Laura Kennedy | Green | GREEN |  |  |
| 1922 | 1.6.3.7 | Non-SIT LDSO Participants submit Final QAD |  | 25d | 2025-04-21 | 2025-05-23 | 1830SS, 1921SS |  |  | 2025-04-21 | 2025-05-23 | 26d | 49d | 0d |  |  | Participants | Participants | S&A Qualification | 145.33 | 6.11 | Laura Kennedy | Green | GREEN |  |  |
| 1923 | 1.6.3.8 | Non-SIT LDSO QT Participants have submitted their final QAD | milestone | 0d | 2025-05-23 | 2025-05-23 | 1922 |  |  | 2025-05-23 | 2025-05-23 | 0d | 49d | 0d |  |  | Participants | Participants | S&A Qualification | 177.71 | 6.11 | Laura Kennedy | Green | GREEN | T3-QU-0088 | QAG |
| 1924 | 1.6.3.9 | Completion of Code Bodies review of the Final QAD |  | 20d | 2025-05-26 | 2025-06-20 | 1923 |  |  | 2025-05-26 | 2025-06-20 | 19d | 49d | 40d |  |  | Code Bodies | Code Bodies | S&A Qualification | 180.33 | 6.11 | Laura Kennedy | Green | GREEN |  |  |
| 1925 | 1.6.3.10 | QAD Sign Off Deadline (Non-SIT LDSOs) | milestone | 0d | 2025-08-22 | 2025-08-22 | 1924FS+5d, 1575, 1827 |  |  | 2025-08-22 | 2025-08-22 | 1d | 9d | 0d |  |  | Participants | Participants | S&A Qualification | 268.71 | 6.11 | Laura Kennedy | Green | GREEN |  |  |
| 1926 | 1.6.3.11 | BSC PAB & REC Manager approval of Qualification for Non-SIT LDSOs | milestone | 0d | 2025-09-10 | 2025-09-10 | 1925FS+13d |  |  | 2025-09-11 | 2025-09-11 | 0d | 9d | 0d |  |  | Non-SIT LDSO | Non-SIT LDSO | S&A Qualification | 287.71 | 6.12 | Ben Wickins | Green | GREEN | T2-QU-0500 | QAG (Non-SIT LDSO) |
| 1927 | 1.6.4 | **MHHS Qualification - Qualification Waves** |  | 814d? | 2023-12-18 A | 2027-01-28 |  | 44% | 454.9d? | 2023-12-18 | 2027-01-28 | 574d | 235d |  |  | -0 | N/A | N/A | S&A Qualification | -131.67 | 5.24 | N/A |  |  |  |  |
| 1928 | 1.6.4.1 | **Qualification Wave Prep** |  | 539d? | 2023-12-18 A | 2026-01-08 |  | 68% | 171d? | 2023-12-18 | 2025-12-26 | 424d | 510d |  |  | -0 | N/A | N/A | S&A Qualification | -131.67 | 5.24 | N/A |  |  |  |  |
| 1929 | 1.6.4.1.1 | **Non-SIT Supplier and Agent Test Approach and Plan** |  | 119d | 2023-12-18 A | 2024-05-30 A |  | 100% |  | 2023-12-18 | 2024-05-30 | 118d |  |  |  | -0 | N/A | N/A | S&A Qualification | -133.67 | 5.24 | N/A |  |  |  |  |
| 1930 | 1.6.4.1.1.1 | Draft Non-SIT S&A Test Approach and Plan |  | 50d | 2023-12-18 A | 2024-02-23 A |  | 100% |  | 2023-12-18 | 2024-02-23 | 50d |  |  | finish no earlier than 2024-02-23 |  | Non-SIT S&A QT Test Team | Non-SIT S&A QT Test Team | S&A Qualification |  | 5.24 | Laura Kennedy | Complete | COMPLETE |  |  |
| 1931 | 1.6.4.1.1.2 | Internal Review of Non-SIT S&A Test Approach and Plan (Code Bodies and MHHSP) |  | 10d | 2024-02-26 A | 2024-03-08 A | 1930 | 100% |  | 2024-02-26 | 2024-03-08 | 10d |  |  |  |  | Code Bodies, SI Team, SRO | Code Bodies, SI Team, SRO | S&A Qualification |  | 5.24 | Laura Kennedy | Complete | COMPLETE |  |  |
| 1932 | 1.6.4.1.1.3 | Issue Non-SIT S&A Test Approach and Plan for Consultation |  | 15d | 2024-03-18 A | 2024-04-05 A | 1931 | 100% |  | 2024-03-18 | 2024-04-05 | 15d |  |  | start no earlier than 2024-03-18 |  | Participants | Participants | S&A Qualification |  | 5.24 | Laura Kennedy | Complete | COMPLETE |  |  |
| 1933 | 1.6.4.1.1.4 | Update Non-SIT S&A Test Approach and Plan Post-Consultation |  | 10d | 2024-04-08 A | 2024-04-19 A | 1932 | 100% |  | 2024-04-08 | 2024-04-19 | 10d |  |  |  |  | Non-SIT S&A QT Test Team | Non-SIT S&A QT Test Team | S&A Qualification |  | 5.24 | Laura Kennedy | Complete | COMPLETE |  |  |
| 1934 | 1.6.4.1.1.5 | QWG Endorsement of Non-SIT S&A Test Approach and Plan |  | 1d | 2024-05-14 A | 2024-05-14 A |  | 100% |  | 2024-05-14 | 2024-05-14 | 1d |  |  | finish no earlier than 2024-05-14 |  | Non-SIT S&A QT Test Team | Non-SIT S&A QT Test Team | S&A Qualification |  | 5.24 | Laura Kennedy | Complete | COMPLETE |  |  |
| 1935 | 1.6.4.1.1.6 | QAG Approval of Non-SIT S&A Test Approach and Plan | milestone | 0d | 2024-05-23 A | 2024-05-23 A | 1934FS+7d | 100% |  | 2024-05-23 | 2024-05-23 | 0d |  |  |  |  | Non-SIT S&A QT Test Team | Non-SIT S&A QT Test Team | S&A Qualification |  | 5.25 | Laura Kennedy | Complete | COMPLETE | T3-QU-0089 | QAG |
| 1936 | 1.6.4.1.1.7 | BSC & REC PAB Approval of Non-SIT S&A Test Approach and Plan | milestone | 0d | 2024-05-30 A | 2024-05-30 A | 1935FS+5d | 100% |  | 2024-05-30 | 2024-05-30 | 0d |  |  |  |  | Code Bodies | Code Bodies | S&A Qualification |  | 5.25 | Laura Kennedy | Complete | COMPLETE | T3-QU-0090 | QAG |

Notes:
- 1910: 25/09/24 - Forecast has moved to 07/04/25, this will be baseliend once CR55 is approved.
- 1916: 25/09/24 - Forecast has moved to 06/01/25, this will be baseliend once CR55 is approved.
- 1917: 25/09/24 - Forecast has moved to 13/02/25, this will be baseliend once CR55 is approved.
- 1919: 25/09/24 - Forecast has moved to 04/04/25, this will be baseliend once CR55 is approved.
- 1920: 25/09/24 - Forecast has moved to 04/04/25, this will be baseliend once CR55 is approved.
- 1921: 25/09/24 - Forecast has moved to 07/04/25, this will be baseliend once CR55 is approved.
- 1925: 18/09/24 - Adding dependency so the milestone is dependent on SIT LDSO MVC.
- 1926: 13/11/24 - Title amended to remove 'Start of Migration', as this was incorrect. This was a duplicate, the duplicate has been removed and dependencies now correctly linked to this.

| ID | WBS | Task | Type | Duration | Start | Finish | Predecessors | Complete | Remaining | Baseline start | Baseline finish | Baseline duration | Total slack | Free slack | Constraint | Baseline cost | Responsible | Involved | Text9 | Task Status | Update Version | MHHS Resource Name | Sched Status | RAG | Milestone ID | Text29 | Tier |
| --- | --- | --- | --- | --- | --- | --- | --- | --- | --- | --- | --- | --- | --- | --- | --- | --- | --- | --- | --- | --- | --- | --- | --- | --- | --- | --- | --- |
| 1937 | 1.6.4.1.2 | **QT Test Data Approach and Plan** |  | 64d | 2024-04-19 A | 2024-07-18 A |  | 100% |  | 2024-04-19 | 2024-07-18 | 64d |  |  |  | -0 | N/A | N/A | S&A Qualification | -133.67 | 5.24 | N/A |  |  |  |  |  |
| 1938 | 1.6.4.1.2.1 | QT Test Data Approach agreed as part of the Non-SIT Supplier and Agent Test Approach and Plan | milestone | 0d | 2024-04-19 A | 2024-04-19 A | 1933 | 100% |  | 2024-04-19 | 2024-04-19 | 0d |  |  |  |  | Non-SIT S&A QT Test Team, Participants | Non-SIT S&A QT Test Team, Participants | S&A Qualification |  | 5.24 | Laura Kennedy | Complete | COMPLETE |  |  |  |
| 1939 | 1.6.4.1.2.2 | Draft Test Data Approach and Plan for QT |  | 10d | 2024-05-06 A | 2024-05-17 A | 1938 | 100% |  | 2024-05-06 | 2024-05-17 | 10d |  |  |  |  | Non-SIT S&A QT Test Team | Non-SIT S&A QT Test Team | S&A Qualification |  | 5.24 | Laura Kennedy | Complete | COMPLETE |  |  |  |
| 1940 | 1.6.4.1.2.3 | Internal Review (Code Bodies and MHHSP) of QT Test Data Approach and Plan |  | 15d | 2024-05-20 A | 2024-06-07 A | 1939 | 100% |  | 2024-05-20 | 2024-06-07 | 10d |  |  |  |  | Code Bodies, SI Team, SRO | Code Bodies, SI Team, SRO | S&A Qualification |  | 5.24 | Laura Kennedy | Complete | COMPLETE |  |  |  |
| 1941 | 1.6.4.1.2.4 | Issue QT Test Data Approach and Plan for Industry Consultation |  | 10d | 2024-06-10 A | 2024-06-21 A | 1940 | 100% |  | 2024-06-10 | 2024-06-21 | 10d |  |  |  |  | Participants | Participants | S&A Qualification |  | 5.24 | Laura Kennedy | Complete | COMPLETE |  |  |  |
| 1942 | 1.6.4.1.2.5 | Update QT Test Approach and Plan Post Industry Consultation |  | 5d | 2024-06-24 A | 2024-06-28 A | 1941 | 100% |  | 2024-06-24 | 2024-06-28 | 10d |  |  |  |  | Non-SIT S&A QT Team | Non-SIT S&A QT Team | S&A Qualification |  | 5.24 | Laura Kennedy | Complete | COMPLETE |  |  |  |
| 1943 | 1.6.4.1.2.6 | QWG Endorsement of Test Data Approach and Plan |  | 1d | 2024-07-09 A | 2024-07-09 A | 1942FS+6d | 100% |  | 2024-07-09 | 2024-07-09 | 1d |  |  |  |  | Non-SIT S&A QT Test Team | Non-SIT S&A QT Test Team | S&A Qualification |  | 5.24 | Laura Kennedy | Complete | COMPLETE |  |  |  |
| 1944 | 1.6.4.1.2.7 | QAG Approval of QT Test Data Approach and Plan | milestone | 0d | 2024-07-18 A | 2024-07-18 A | 1943FS+7d | 100% |  | 2024-07-18 | 2024-07-18 | 0d |  |  |  |  | Non-SIT S&A QT Test Team | Non-SIT S&A QT Test Team | S&A Qualification |  | 5.29 | Laura Kennedy | Complete | COMPLETE | T3-QU-0091 | QAG |  |
| 1945 | 1.6.4.1.3 | **QT Functional Test Scenarios and Test Cases** |  | 59d | 2024-03-04 A | 2024-05-23 A |  | 100% |  | 2024-03-04 | 2024-05-23 | 59d |  |  |  | -0 | N/A | N/A | S&A Qualification | -133.67 | 5.24 | N/A |  |  |  |  |  |
| 1946 | 1.6.4.1.3.1 | Draft Test Scenarios and Test Case list - Batch 1 |  | 10d | 2024-03-04 A | 2024-03-15 A |  | 100% |  | 2024-03-04 | 2024-03-15 | 10d |  |  | finish no earlier than 2024-03-15 |  | Non-SIT S&A QT Test Team, Code Bodies | Non-SIT S&A QT Test Team, Code Bodies | S&A Qualification |  | 5.24 | Laura Kennedy | Complete | COMPLETE |  |  |  |
| 1947 | 1.6.4.1.3.2 | Issue Batch 1 for Consultation |  | 15d | 2024-03-18 A | 2024-04-05 A | 1946 | 100% |  | 2024-03-18 | 2024-04-05 | 15d |  |  | start no earlier than 2024-03-18 |  | Participants | Participants | S&A Qualification |  | 5.24 | Laura Kennedy | Complete | COMPLETE |  |  |  |
| 1948 | 1.6.4.1.3.3 | Gap analysis against QT Requirements |  | 8d | 2024-03-18 A | 2024-03-27 A | 1946 | 100% |  | 2024-03-18 | 2024-03-27 | 8d |  |  |  |  | Non-SIT S&A QT Test Team | Non-SIT S&A QT Test Team | S&A Qualification |  | 5.24 | Laura Kennedy | Complete | COMPLETE |  |  |  |
| 1949 | 1.6.4.1.3.4 | Update Test Scenarios and Test Case list - Batch 2 |  | 6d | 2024-03-28 A | 2024-04-04 A | 1948 | 100% |  | 2024-03-28 | 2024-04-04 | 6d |  |  |  |  | Non-SIT S&A QT Test Team, Code Bodies | Non-SIT S&A QT Test Team, Code Bodies | S&A Qualification |  | 5.24 | Laura Kennedy | Complete | COMPLETE |  |  |  |
| 1950 | 1.6.4.1.3.5 | Issue Batch 2 for consultation |  | 10d | 2024-04-05 A | 2024-04-18 A | 1949 | 100% |  | 2024-04-05 | 2024-04-18 | 10d |  |  |  |  | Participants | Participants | S&A Qualification |  | 5.24 | Laura Kennedy | Complete | COMPLETE |  |  |  |
| 1951 | 1.6.4.1.3.6 | Update Batch 2 post consultation |  | 10d | 2024-04-19 A | 2024-05-02 A | 1950 | 100% |  | 2024-04-19 | 2024-05-02 | 10d |  |  |  |  | Non-SIT S&A QT Test Team, Code Bodies | Non-SIT S&A QT Test Team, Code Bodies | S&A Qualification |  | 5.24 | Laura Kennedy | Complete | COMPLETE |  |  |  |
| 1952 | 1.6.4.1.3.7 | QWG Endorsement of Batch 1 and 2 |  | 1d | 2024-05-14 A | 2024-05-14 A |  | 100% |  | 2024-05-14 | 2024-05-14 | 1d |  |  | finish no earlier than 2024-05-14 |  | Non-SIT S&A QT Test Team | Non-SIT S&A QT Test Team, Code Bodies, Participants | S&A Qualification |  | 5.24 | Laura Kennedy | Complete | COMPLETE |  |  |  |
| 1953 | 1.6.4.1.3.8 | QAG Approval of QT Functional Test Scenarios and Test Cases Batches 1 and 2 | milestone | 0d | 2024-05-23 A | 2024-05-23 A | 1952FS+7d | 100% |  | 2024-05-23 | 2024-05-23 | 0d |  |  |  |  | Non-SIT S&A QT Test Team | Non-SIT S&A QT Test Team, Code Bodies, Participants | S&A Qualification |  | 5.25 | Laura Kennedy | Complete | COMPLETE | T3-QU-0092 | QAG |  |
| 1954 | 1.6.4.1.4 | **QT Migration Test Scenarios and Test Cases** |  | 54d | 2024-05-06 A | 2024-07-18 A |  | 100% |  | 2024-05-06 | 2024-07-18 | 54d |  |  |  |  | N/A | N/A | S&A Qualification |  | 5.25 | N/A |  |  |  |  |  |
| 1955 | 1.6.4.1.4.1 | Draft Test Scenarios and Test Case list - Batch 1 |  | 20d | 2024-05-06 A | 2024-05-31 A | 987FS+12d | 100% |  | 2024-05-06 | 2024-05-31 | 20d |  |  |  |  | Non-SIT S&A QT Test Team, Code Bodies | Non-SIT S&A QT Test Team, Code Bodies | S&A Qualification |  | 5.25 | Laura Kennedy | Complete | COMPLETE |  |  |  |
| 1956 | 1.6.4.1.4.2 | Issue Batch 1 for Consultation |  | 10d | 2024-06-03 A | 2024-06-14 A | 1955 | 100% |  | 2024-06-03 | 2024-06-14 | 10d |  |  |  |  | Participants | Participants | S&A Qualification |  | 5.25 | Laura Kennedy | Complete | COMPLETE |  |  |  |
| 1957 | 1.6.4.1.4.3 | Update Batch 1 Post Consultation |  | 10d | 2024-06-17 A | 2024-06-28 A | 1956 | 100% |  | 2024-06-17 | 2024-06-28 | 10d |  |  |  |  | Non-SIT S&A QT Test Team | Non-SIT S&A QT Test Team | S&A Qualification |  | 5.25 | Laura Kennedy | Complete | COMPLETE |  |  |  |
| 1958 | 1.6.4.1.4.4 | QWG Endorsement of Batch 1 | milestone | 0d | 2024-07-09 A | 2024-07-09 A | 1957FS+7d | 100% |  | 2024-07-09 | 2024-07-09 | 0d |  |  |  |  | Non-SIT S&A QT Test Team | Non-SIT S&A QT Test Team, Code Bodies, Participants | S&A Qualification |  | 5.25 | Laura Kennedy | Complete | COMPLETE |  |  |  |
| 1959 | 1.6.4.1.4.5 | QAG Approval of QT Migration Test Scenarios and Test Cases Batches 1 | milestone | 0d | 2024-07-18 A | 2024-07-18 A | 1958FS+7d | 100% |  | 2024-07-18 | 2024-07-18 | 0d |  |  |  |  | Non-SIT S&A QT Test Team | Non-SIT S&A QT Test Team, Code Bodies, Participants | S&A Qualification |  | 5.29 | Laura Kennedy | Complete | COMPLETE | T3-QU-0119 | QAG |  |
| 1960 | 1.6.4.1.5 | **QT Functional (inc NF and Operational) Test Scenarios and Test Cases** |  | 184d | 2024-11-05 A | 2025-07-18 |  | 2% | 179.7d | 2024-11-04 | 2024-12-27 | 0d | 574d |  |  |  | Non-SIT S&A QT Test Team |  | S&A Qualification | -721.67 |  | Laura Kennedy |  |  |  |  |  |
| 1961 | 1.6.4.1.5.1 | Draft Test Scenarios and Test Case list - Batch 3 |  | 141d | 2024-11-05 A | 2025-05-20 | 874FS-1d, 1327FS-1d | 3% | 137d | 2024-11-05 | 2024-12-02 | 0d | 574d | 0d |  |  | Non-SIT S&A QT Test Team |  | S&A Qualification |  | 6.11 | Laura Kennedy | Red | RED |  |  |  |
| 1962 | 1.6.4.1.5.2 | Issue Batch 3 for Consultation |  | 10d | 2025-05-21 | 2025-06-03 | 1961 |  |  | 2024-12-03 | 2024-12-16 | 0d | 574d | 0d |  |  | Non-SIT S&A QT Test Team |  | S&A Qualification | 175.33 | 6.11 | Laura Kennedy | Red | RED |  |  |  |
| 1963 | 1.6.4.1.5.3 | Update Batch 3 Post Consultation |  | 20d | 2025-06-04 | 2025-07-01 | 1962 |  |  | 2024-12-17 | 2025-01-13 | 0d | 574d | 0d |  |  | Non-SIT S&A QT Test Team |  | S&A Qualification | 189.33 | 6.11 | Laura Kennedy | Red | RED |  |  |  |
| 1964 | 1.6.4.1.5.4 | QWG Endorsement of Batch 3 | milestone | 0d | 2025-07-10 | 2025-07-10 | 1963FS+7d |  |  | 2025-01-22 | 2025-01-22 | 0d | 574d | 0d |  |  | Non-SIT S&A QT Test Team |  | S&A Qualification | 225.71 | 6.11 | Laura Kennedy | Red | RED |  |  |  |
| 1965 | 1.6.4.1.5.5 | QAG Approval of QT Functional Test Scenarios and Test Cases Batches 3 | milestone | 0d | 2025-07-18 | 2025-07-18 | 1964FS+6d |  |  | 2025-01-30 | 2025-01-30 | 0d | 574d | 0d |  |  | Non-SIT S&A QT Test Team |  | S&A Qualification | 233.71 | 6.11 | Laura Kennedy | Red | RED | T3-QU-0123 | QAG | T3 |

| ID | WBS | Task | Duration | Start | Finish | Predecessors | Complete | Remaining | Baseline start | Baseline finish | Baseline duration | Total slack | Free slack | Constraint | Responsible | Text9 | Task Status | Update Version | Sched Status | MHHS Resource Name | RAG |
| --- | --- | --- | --- | --- | --- | --- | --- | --- | --- | --- | --- | --- | --- | --- | --- | --- | --- | --- | --- | --- | --- |
| 1966 | 1.6.4.1.6 | **Qualification Testing Framework (Test Stubs and Supporting UI)** | 509d? | 2024-01-29 A | 2026-01-08 |  | 68% | 161.02d? | 2024-01-29 | 2026-01-08 | 0d | 510d |  |  | Non-SIT S&A QT Test Team | S&A Qualification | -742.67 | 6.12 | Overdue Start | Laura Kennedy |  |
| 1967 | 1.6.4.1.6.1 | Proof of Concept for QTF Completion | 45d | 2024-01-29 A | 2024-03-29 A |  | 100% |  | 2024-01-29 | 2024-03-29 | 0d |  |  | finish no earlier than 2024-03-29 | Non-SIT S&A QT Test Team | S&A Qualification |  | 6.12 | Complete | Laura Kennedy | COMPLETE |
| 1968 | 1.6.4.1.6.2 | Discovery and Mobilisation | 25d | 2024-04-01 A | 2024-05-03 A | 1967 | 100% |  | 2024-04-01 | 2024-05-03 | 0d |  |  | finish no earlier than 2024-05-03 | Non-SIT S&A QT Test Team | S&A Qualification |  | 6.12 | Complete | Laura Kennedy | COMPLETE |
| 1969 | 1.6.4.1.6.3 | **Agile DBT of Qualification Testing Framework** | 83d | 2024-04-24 A | 2024-08-16 A |  | 100% |  | 2024-04-24 | 2024-08-16 | 0d |  |  |  | Non-SIT S&A QT Test Team | S&A Qualification | -742.67 | 6.12 | Overdue Start | Laura Kennedy |  |
| 1970 | 1.6.4.1.6.3.1 | **User Interface (UI)** | 48d | 2024-04-24 A | 2024-06-28 A |  | 100% |  | 2024-04-24 | 2024-06-28 | 0d |  |  |  | Non-SIT S&A QT Test Team | S&A Qualification | -742.67 | 6.12 | Overdue Start | Laura Kennedy |  |
| 1971 | 1.6.4.1.6.3.1.1 | UI Wireframe | 48d | 2024-04-24 A | 2024-06-28 A |  | 100% |  | 2024-04-24 | 2024-06-28 | 0d |  |  | finish no earlier than 2024-06-28 | Non-SIT S&A QT Test Team | S&A Qualification |  | 6.12 | Complete | Laura Kennedy | COMPLETE |
| 1972 | 1.6.4.1.6.3.1.2 | UI Standards | 35d | 2024-05-13 A | 2024-06-28 A | 1971FS+13d | 100% |  | 2024-05-13 | 2024-06-28 | 0d |  |  | finish no earlier than 2024-06-28 | Non-SIT S&A QT Test Team | S&A Qualification |  | 6.12 | Complete | Laura Kennedy | COMPLETE |
| 1973 | 1.6.4.1.6.3.1.3 | Elexon Branding Sylesheet | 2d | 2024-05-17 A | 2024-05-20 A | 1972FS+10d | 100% |  | 2024-05-17 | 2024-05-20 | 0d |  |  | finish no earlier than 2024-05-20 | Non-SIT S&A QT Test Team | S&A Qualification |  | 6.12 | Complete | Laura Kennedy | COMPLETE |
| 1974 | 1.6.4.1.6.3.1.4 | Elexon Branding QTF Logo | 2d | 2024-05-31 A | 2024-06-03 A | 1973FS+20d | 100% |  | 2024-05-31 | 2024-06-03 | 0d |  |  | finish no earlier than 2024-06-03 | Non-SIT S&A QT Test Team | S&A Qualification |  | 6.12 | Complete | Laura Kennedy | COMPLETE |
| 1975 | 1.6.4.1.6.3.2 | **Design, Build, Test** | 70d | 2024-05-13 A | 2024-08-16 A |  | 100% |  | 2024-05-13 | 2024-08-16 | 0d |  |  |  | Non-SIT S&A QT Test Team | S&A Qualification | -742.67 | 6.12 | Overdue Start | Laura Kennedy |  |
| 1976 | 1.6.4.1.6.3.2.1 | Core UI Screens | 60d | 2024-05-13 A | 2024-08-02 A | 1972SS | 100% |  | 2024-05-13 | 2024-08-02 | 0d |  |  | finish no earlier than 2024-08-02 | Non-SIT S&A QT Test Team | S&A Qualification |  | 6.12 | Complete | Laura Kennedy | COMPLETE |
| 1977 | 1.6.4.1.6.3.2.2 | Tooling (Trigger Files / Template Generators) | 70d | 2024-05-13 A | 2024-08-16 A | 1971SS+13d | 100% |  | 2024-05-13 | 2024-08-16 | 0d |  |  | finish no earlier than 2024-08-16 | Non-SIT S&A QT Test Team | S&A Qualification |  | 6.12 | Complete | Laura Kennedy | COMPLETE |
| 1978 | 1.6.4.1.6.3.2.3 | Database Schema | 50d | 2024-05-13 A | 2024-07-19 A | 1971SS+13d | 100% |  | 2024-05-13 | 2024-07-19 | 0d |  |  | finish no earlier than 2024-07-19 | Non-SIT S&A QT Test Team | S&A Qualification |  | 6.12 | Complete | Laura Kennedy | COMPLETE |
| 1979 | 1.6.4.1.6.3.2.4 | Core API's | 60d | 2024-05-13 A | 2024-08-02 A | 1971SS+13d | 100% |  | 2024-05-13 | 2024-08-02 | 0d |  |  | finish no earlier than 2024-08-02 | Non-SIT S&A QT Test Team | S&A Qualification |  | 6.12 | Complete | Laura Kennedy | COMPLETE |
| 1980 | 1.6.4.1.6.4 | QTF Test Cases DBT Refinement, Execution and Results Validation, Defect Management, Error Handling | 184d | 2024-11-05 A | 2025-07-18 | 1965FF, 1959FF, 1961SS | 10% | 164.8d | 2024-11-05 | 2025-01-31 | 0d | 574d | 0d | start no earlier than 2024-08-19 | Non-SIT S&A QT Test Team | S&A Qualification |  | 6.12 | Red | Laura Kennedy | RED |
| 1981 | 1.6.4.1.6.5 | **Environments** | 390d | 2024-04-15 A | 2025-10-10 |  | 91% | 36.89d | 2024-04-15 | 2025-07-31 | 0d | 574d |  |  | Non-SIT S&A QT Test Team | S&A Qualification | -742.67 | 6.12 | Overdue Start | Laura Kennedy |  |
| 1982 | 1.6.4.1.6.5.1 | **Azure Devops** | 173d | 2024-04-15 A | 2024-12-11 A |  | 100% |  | 2024-04-15 | 2024-12-11 | 0d |  |  |  | Non-SIT S&A QT Test Team | S&A Qualification | -742.67 | 6.12 | Overdue Start | Laura Kennedy |  |
| 1983 | 1.6.4.1.6.5.1.1 | **QFT ADO Development Instance** | 15d | 2024-04-15 A | 2024-05-03 A |  | 100% |  | 2024-04-15 | 2024-05-03 | 0d |  |  |  | Non-SIT S&A QT Test Team | S&A Qualification | -742.67 | 6.12 | Overdue Start | Laura Kennedy |  |
| 1984 | 1.6.4.1.6.5.1.1.1 | Elexon Instance Setup for QTF Build | 5d | 2024-04-15 A | 2024-04-19 A | 1968SS+10d | 100% |  | 2024-04-15 | 2024-04-19 | 0d |  |  | finish no earlier than 2024-04-19 | Non-SIT S&A QT Test Team | S&A Qualification |  | 6.12 | Complete | Laura Kennedy | COMPLETE |
| 1985 | 1.6.4.1.6.5.1.1.2 | Configuration and User Access | 10d | 2024-04-22 A | 2024-05-03 A | 1984 | 100% |  | 2024-04-22 | 2024-05-03 | 0d |  |  | finish no earlier than 2024-05-03 | Non-SIT S&A QT Test Team | S&A Qualification |  | 6.12 | Complete | Laura Kennedy | COMPLETE |
| 1986 | 1.6.4.1.6.5.1.2 | **MHHSP ADO Instance** | 102d | 2024-07-23 A | 2024-12-11 A |  | 100% |  | 2024-07-23 | 2024-12-11 | 0d |  |  |  | Non-SIT S&A QT Test Team | S&A Qualification | -742.67 | 6.12 | Overdue Start | Laura Kennedy |  |
| 1987 | 1.6.4.1.6.5.1.2.1 | MHHSP Instance Setup for QTF Production | 29d | 2024-07-23 A | 2024-08-30 A | 1993SS+41d | 100% |  | 2024-07-23 | 2024-08-30 | 0d |  |  | finish no earlier than 2024-08-30 | Non-SIT S&A QT Test Team | S&A Qualification |  | 6.12 | Complete | Laura Kennedy | COMPLETE |
| 1988 | 1.6.4.1.6.5.1.2.2 | Configuration and User Access | 73d | 2024-09-02 A | 2024-12-11 A | 1987 | 100% |  | 2024-09-02 | 2024-12-11 | 0d |  |  | finish no earlier than 2024-09-27 | Non-SIT S&A QT Test Team | S&A Qualification |  | 6.12 | Complete | Laura Kennedy | COMPLETE |
| 1989 | 1.6.4.1.6.5.2 | **Temporary Development Environment** | 35d | 2024-04-15 A | 2024-05-31 A |  | 100% |  | 2024-04-15 | 2024-05-31 | 0d |  |  |  | Non-SIT S&A QT Test Team | S&A Qualification | -742.67 | 6.12 | Overdue Start | Laura Kennedy |  |
| 1990 | 1.6.4.1.6.5.2.1 | Design | 15d | 2024-04-15 A | 2024-05-03 A | 1968SS+10d | 100% |  | 2024-04-15 | 2024-05-03 | 0d |  |  | finish no earlier than 2024-05-03 | Non-SIT S&A QT Test Team | S&A Qualification |  | 6.12 | Complete | Laura Kennedy | COMPLETE |
| 1991 | 1.6.4.1.6.5.2.2 | Build and Deployment | 20d | 2024-05-06 A | 2024-05-31 A | 1985, 1990 | 100% |  | 2024-05-06 | 2024-05-31 | 0d |  |  | finish no earlier than 2024-05-31 | Non-SIT S&A QT Test Team | S&A Qualification |  | 6.12 | Complete | Laura Kennedy | COMPLETE |

| ID | WBS | Task | Duration | Start | Finish | Predecessors | Complete | Remaining | Baseline start | Baseline finish | Baseline duration | Total slack | Constraint | Responsible | Text9 | Task Status | Update Version | Sched Status | MHHS Resource Name | RAG |
| --- | --- | --- | --- | --- | --- | --- | --- | --- | --- | --- | --- | --- | --- | --- | --- | --- | --- | --- | --- | --- |
| 1992 | 1.6.4.1.6.5.3 | **Dev, Test & Prod Environment Requirements + Design** | 135d | 2024-05-27 A | 2024-11-29 A |  | 100% |  | 2024-05-27 | 2024-11-29 | 0d |  |  | Non-SIT S&A QT Test Team | S&A Qualification | -742.67 | 6.12 | Overdue Start | Laura Kennedy |  |
| 1993 | 1.6.4.1.6.5.3.1 | Design (including Security Review) | 135d | 2024-05-27 A | 2024-11-29 A | 1968FS+15d | 100% |  | 2024-05-27 | 2024-11-29 | 0d |  | finish no earlier than 2024-08-30 | Non-SIT S&A QT Test Team | S&A Qualification |  | 6.12 | Complete | Laura Kennedy | COMPLETE |
| 1994 | 1.6.4.1.6.5.3.2 | Hub Development Dev/Test | 20d | 2024-06-10 A | 2024-07-05 A | 1993SS+10d | 100% |  | 2024-06-10 | 2024-07-05 |  |  |  | Non-SIT S&A QT Test Team | S&A Qualification |  | 6.12 | Complete | Laura Kennedy | COMPLETE |
| 1995 | 1.6.4.1.6.5.3.3 | Hub Deployment | 20d | 2024-06-10 A | 2024-07-05 A | 1993FS+10d, 1994 | 100% |  | 2024-06-10 | 2024-07-05 | 0d |  | finish no earlier than 2024-07-05 | Non-SIT S&A QT Test Team | S&A Qualification |  | 6.12 | Complete | Laura Kennedy | COMPLETE |
| 1996 | 1.6.4.1.6.5.3.4 | Development Envn. Deployment | 53.8d | 2024-07-08 A | 2024-09-19 A |  | 100% |  | 2024-07-08 | 2024-09-19 | 0d |  | finish no earlier than 2024-08-30 | Non-SIT S&A QT Test Team | S&A Qualification |  | 6.12 | Complete | Laura Kennedy | COMPLETE |
| 1997 | 1.6.4.1.6.5.3.5 | Test Envn. Deployment | 10d | 2024-09-19 A | 2024-10-03 A | 1996 | 100% |  | 2024-09-19 | 2024-10-03 | 0d |  | finish no earlier than 2024-09-13 | Non-SIT S&A QT Test Team | S&A Qualification |  | 6.12 | Complete | Laura Kennedy | COMPLETE |
| 1998 | 1.6.4.1.6.5.3.6 | Production Envn. Deployment | 25d | 2024-10-03 A | 2024-11-07 A | 1997 | 100% |  | 2024-10-03 | 2024-11-07 | 0d |  | finish no earlier than 2024-10-18 | Non-SIT S&A QT Test Team | S&A Qualification |  | 6.12 | Complete | Laura Kennedy | COMPLETE |
| 1999 | 1.6.4.1.6.5.4 | **QTF Deployment into Production** | 180d | 2025-02-03 | 2025-10-10 |  |  |  | 2025-02-03 | 2025-04-25 | 0d | 574d |  | Non-SIT S&A QT Test Team | S&A Qualification | -742.67 | 6.12 | Overdue Start | Laura Kennedy |  |
| 2000 | 1.6.4.1.6.5.4.1 | App Deployment | 60d | 2025-07-21 | 2025-10-10 | 1980, 1998 |  |  | 2025-02-03 | 2025-04-25 | 0d | 574d | start no earlier than 2025-02-03 | Non-SIT S&A QT Test Team | S&A Qualification | 236.33 | 6.12 | Red | Laura Kennedy | RED |
| 2001 | 1.6.4.1.6.5.4.2 | Smoke Test | 2d | 2025-02-03 | 2025-02-04 |  |  |  | 2025-02-03 | 2025-02-04 | 0d | 752d | finish no earlier than 2025-02-04 | Non-SIT S&A QT Test Team | S&A Qualification | 68.33 | 6.12 | Green | Laura Kennedy | GREEN |
| 2002 | 1.6.4.1.6.5.4.3 | PEN Test | 2d | 2025-02-05 | 2025-02-06 |  |  |  | 2025-02-05 | 2025-02-06 | 0d | 750d | finish no earlier than 2025-02-06 | Non-SIT S&A QT Test Team | S&A Qualification | 70.33 | 6.12 | Green | Laura Kennedy | GREEN |
| 2003 | 1.6.4.1.6.5.4.4 | Regression Test | 10d | 2025-02-07 | 2025-02-20 |  |  |  | 2025-02-07 | 2025-02-20 | 0d | 740d | finish no earlier than 2025-02-20 | Non-SIT S&A QT Test Team | S&A Qualification | 72.33 | 6.12 | Green | Laura Kennedy | GREEN |
| 2004 | 1.6.4.1.6.5.5 | **DIP Onboarding (UIT)** | 101d | 2024-07-26 A | 2024-12-13 |  | 83% | 16.82d | 2024-07-26 | 2024-11-29 | 0d | 789d |  | Non-SIT S&A QT Test Team | S&A Qualification | -742.67 | 6.12 | Overdue Start | Laura Kennedy |  |
| 2005 | 1.6.4.1.6.5.5.1 | DIP Simulator | 15d | 2024-07-26 A | 2024-08-15 A |  | 100% |  | 2024-07-26 | 2024-08-15 | 0d |  | finish no earlier than 2024-08-15 | Non-SIT S&A QT Test Team | S&A Qualification |  | 6.12 | Complete | Laura Kennedy | COMPLETE |
| 2006 | 1.6.4.1.6.5.5.2 | DIP (UIT) Instance available for Onboarding | 1d | 2024-08-05 A | 2024-08-05 A |  | 100% |  | 2024-08-05 | 2024-08-05 | 0d |  | start no earlier than 2024-08-05 | Non-SIT S&A QT Test Team | S&A Qualification |  | 6.12 | Complete | Laura Kennedy | COMPLETE |
| 2007 | 1.6.4.1.6.5.5.3 | DIP (UIT) Portal | 1d | 2024-09-03 A | 2024-09-03 A |  | 100% |  | 2024-09-03 | 2024-09-03 | 0d |  | start no earlier than 2024-09-03 | Non-SIT S&A QT Test Team | S&A Qualification |  | 6.12 | Complete | Laura Kennedy | COMPLETE |
| 2008 | 1.6.4.1.6.5.5.4 | DIP (UIT) Onboarding for Development (incl. certificates and security compliance) | 39d | 2024-08-06 A | 2024-09-27 A |  | 100% |  | 2024-08-06 | 2024-09-27 | 0d |  | finish no earlier than 2024-09-27 | Non-SIT S&A QT Test Team | S&A Qualification |  | 6.12 | Complete | Laura Kennedy | COMPLETE |
| 2009 | 1.6.4.1.6.5.5.5 | DIP (UIT) Onboarding for Development Connection Confirmed | 1d | 2024-09-30 A | 2024-09-30 A |  | 100% |  | 2024-09-30 | 2024-09-30 | 0d |  | start no earlier than 2024-09-30 | Non-SIT S&A QT Test Team | S&A Qualification |  | 6.12 | Complete | Laura Kennedy | COMPLETE |
| 2010 | 1.6.4.1.6.5.5.6 | DIP (UIT) Onboarding for Test (incl. certificates and security compliance) | 5d | 2024-10-01 A | 2024-10-07 A |  | 100% |  | 2024-10-01 | 2024-10-07 | 0d |  | finish no earlier than 2024-10-07 | Non-SIT S&A QT Test Team | S&A Qualification |  | 6.12 | Complete | Laura Kennedy | COMPLETE |
| 2011 | 1.6.4.1.6.5.5.7 | DIP (UIT) Onboarding for Test Connection Confirmed | 1d | 2024-10-08 A | 2024-10-08 A |  | 100% |  | 2024-10-08 | 2024-10-08 | 0d |  | start no earlier than 2024-10-08 | Non-SIT S&A QT Test Team | S&A Qualification |  | 6.12 | Complete | Laura Kennedy | COMPLETE |
| 2012 | 1.6.4.1.6.5.5.8 | DIP (UIT) Onboarding for Prod (incl. certificates and security compliance) | 5d | 2024-10-09 A | 2024-10-15 A |  | 100% |  | 2024-10-09 | 2024-10-15 | 0d |  | finish no earlier than 2024-10-15 | Non-SIT S&A QT Test Team | S&A Qualification |  | 6.12 | Complete | Laura Kennedy | COMPLETE |
| 2013 | 1.6.4.1.6.5.5.9 | DIP (UIT) Onboarding for Prod Connection Confirmed | 1d | 2024-10-16 A | 2024-10-16 A |  | 100% |  | 2024-10-16 | 2024-10-16 | 0d |  | start no earlier than 2024-10-16 | Non-SIT S&A QT Test Team | S&A Qualification |  | 6.12 | Complete | Laura Kennedy | COMPLETE |
| 2014 | 1.6.4.1.6.5.5.10 | DIP UIT Test Stubs | 42d | 2024-10-17 A | 2024-12-13 | 2009, 2011, 2013 | 56% | 18.48d | 2024-10-17 | 2024-11-29 | 0d | 789d |  | Non-SIT S&A QT Test Team | S&A Qualification |  | 6.12 | Red | Laura Kennedy | RED |
| 2015 | 1.6.4.1.6.5.6 | **DTN Onboarding** | 115d | 2024-05-20 A | 2024-10-25 A |  | 100% |  | 2024-05-20 | 2024-10-25 | 0d |  |  | Non-SIT S&A QT Test Team | S&A Qualification | -742.67 | 6.12 | Overdue Start | Laura Kennedy |  |
| 2016 | 1.6.4.1.6.5.6.1 | DTN Request Raised for Onboarding | 25d | 2024-05-20 A | 2024-06-21 A |  | 100% |  | 2024-05-20 | 2024-06-21 | 0d |  | start no earlier than 2024-05-20 | Non-SIT S&A QT Test Team | S&A Qualification |  | 6.12 | Complete | Laura Kennedy | COMPLETE |
| 2017 | 1.6.4.1.6.5.6.2 | Setup, configuration of New Host and Test Flags | 5d | 2024-06-24 A | 2024-06-28 A |  | 100% |  | 2024-06-24 | 2024-06-28 | 0d |  | start no earlier than 2024-06-24 | Non-SIT S&A QT Test Team | S&A Qualification |  | 6.12 | Complete | Laura Kennedy | COMPLETE |
| 2018 | 1.6.4.1.6.5.6.3 | New VPN Connection (Test) | 30d | 2024-08-05 A | 2024-09-13 A |  | 100% |  | 2024-08-05 | 2024-09-13 | 0d |  | start no earlier than 2024-08-05 | Non-SIT S&A QT Test Team | S&A Qualification |  | 6.12 | Complete | Laura Kennedy | COMPLETE |
| 2019 | 1.6.4.1.6.5.6.4 | New VPN Connection (Prod) | 30d | 2024-09-16 A | 2024-10-25 A |  | 100% |  | 2024-09-16 | 2024-10-25 | 0d |  | finish no earlier than 2024-10-25 | Non-SIT S&A QT Test Team | S&A Qualification |  | 6.12 | Complete | Laura Kennedy | COMPLETE |
| 2020 | 1.6.4.1.6.5.6.5 | DTN Test Stubs | 10d | 2024-09-16 A | 2024-09-27 A |  | 100% |  | 2024-09-16 | 2024-09-27 | 0d |  | start no earlier than 2024-09-16 | Non-SIT S&A QT Test Team | S&A Qualification |  | 6.12 | Complete | Laura Kennedy | COMPLETE |

Notes:
- 2014: 12/11/24 - Additional time required to configure test stubs, forecast pushed out to reflect this.

| ID | WBS | Task | Type | Duration | Start | Finish | Predecessors | Complete | Remaining | Actual start | Actual finish | Baseline start | Baseline finish | Baseline duration | Total slack | Constraint | Responsible | Text9 | Task Status | Update Version | Sched Status | MHHS Resource Name | RAG |
| --- | --- | --- | --- | --- | --- | --- | --- | --- | --- | --- | --- | --- | --- | --- | --- | --- | --- | --- | --- | --- | --- | --- | --- |
| 2021 | 1.6.4.1.6.5.7 | **Generate Tooling** |  | 334d | 2024-04-22 A | 2025-07-31 |  | 100% |  |  | 2024-09-24 | 2024-04-22 | 2025-07-31 | 0d |  |  | Non-SIT S&A QT Test Team | S&A Qualification | -742.67 | 6.12 | Overdue Start | Laura Kennedy |  |
| 2022 | 1.6.4.1.6.5.7.1 | MPAN Core Generator |  | 25d | 2024-04-22 A | 2024-05-24 A |  | 100% |  |  |  | 2024-04-22 | 2024-05-24 | 0d |  | finish no earlier than 2024-05-24 | Non-SIT S&A QT Test Team | S&A Qualification |  | 6.12 | Complete | Laura Kennedy | COMPLETE |
| 2023 | 1.6.4.1.6.5.7.2 | MPAN File Generator |  | 55d | 2024-05-27 A | 2024-08-09 A |  | 100% |  |  |  | 2024-05-27 | 2024-08-09 | 0d |  | finish no earlier than 2024-08-09 | Non-SIT S&A QT Test Team | S&A Qualification |  | 6.12 | Complete | Laura Kennedy | COMPLETE |
| 2024 | 1.6.4.1.6.5.7.3 | MPAN Template Loader |  | 32d | 2024-08-12 A | 2024-09-24 A |  | 100% |  |  |  | 2024-08-12 | 2024-09-24 | 0d |  | finish no earlier than 2024-09-24 | Non-SIT S&A QT Test Team | S&A Qualification |  | 6.12 | Complete | Laura Kennedy | COMPLETE |
| 2025 | 1.6.4.1.6.5.7.4 | ADO Extract (QTC) From SIT |  | 30d | 2024-05-06 A | 2024-06-14 A |  | 100% |  |  |  | 2024-05-06 | 2024-06-14 | 0d |  | finish no earlier than 2024-06-14 | Non-SIT S&A QT Test Team | S&A Qualification |  | 6.12 | Complete | Laura Kennedy | COMPLETE |
| 2026 | 1.6.4.1.6.5.7.5 | Populate QT ADO |  | 40d | 2024-06-17 A | 2024-08-09 A |  | 100% |  |  |  | 2024-06-17 | 2024-08-09 | 0d |  | finish no earlier than 2024-08-09 | Non-SIT S&A QT Test Team | S&A Qualification |  | 6.12 | Complete | Laura Kennedy | COMPLETE |
| 2027 | 1.6.4.1.6.5.7.6 | Create QTC Spreadsheets |  | 20d | 2024-06-03 A | 2024-06-28 A |  | 100% |  |  |  | 2024-06-03 | 2024-06-28 | 0d |  | finish no earlier than 2024-06-28 | Non-SIT S&A QT Test Team | S&A Qualification |  | 6.12 | Complete | Laura Kennedy | COMPLETE |
| 2028 | 1.6.4.1.6.5.7.7 | Upload QTC Spreadsheets to QTF |  | 20d | 2024-07-01 A | 2024-07-26 A |  | 100% |  |  |  | 2024-07-01 | 2024-07-26 | 0d |  | finish no earlier than 2024-07-26 | Non-SIT S&A QT Test Team | S&A Qualification |  | 6.12 | Complete | Laura Kennedy | COMPLETE |
| 2029 | 1.6.4.1.6.5.7.8 | Create QTC Set / Master QTC Loader |  | 40d | 2024-07-22 A | 2024-09-13 A |  | 100% |  |  |  | 2024-07-22 | 2024-09-13 | 0d |  | finish no earlier than 2024-09-13 | Non-SIT S&A QT Test Team | S&A Qualification |  | 6.12 | Complete | Laura Kennedy | COMPLETE |
| 2030 | 1.6.4.1.6.5.8 | **Test Data** |  | 15d | 2024-06-10 A | 2024-06-28 A |  | 100% |  |  |  | 2024-06-10 | 2024-06-28 | 0d |  |  | Non-SIT S&A QT Test Team | S&A Qualification | -742.67 | 6.12 | Overdue Start | Laura Kennedy |  |
| 2031 | 1.6.4.1.6.5.8.1 | Sample MPAN Data + Attributes from Suppliers |  | 15d | 2024-06-10 A | 2024-06-28 A |  | 100% |  |  |  | 2024-06-10 | 2024-06-28 | 0d |  | finish no earlier than 2024-06-28 | Non-SIT S&A QT Test Team | S&A Qualification |  | 6.12 | Complete | Laura Kennedy | COMPLETE |
| 2032 | 1.6.4.1.6.6 | **MPANs, DIP Messages, Settlement, Consumption, Reference** |  | 423d? | 2024-05-27 A | 2026-01-07 |  | 45% | 234.57d? |  |  | 2024-05-27 | 2026-01-07 | 0d |  |  | Non-SIT S&A QT Test Team | S&A Qualification | -742.67 | 6.12 | Overdue Start | Laura Kennedy |  |
| 2033 | 1.6.4.1.6.6.1 | Create MPAN Data |  | 55d | 2024-05-27 A | 2024-08-09 A |  | 100% |  |  |  | 2024-05-27 | 2024-08-09 | 0d |  | finish no earlier than 2024-08-09 | Non-SIT S&A QT Test Team | S&A Qualification |  | 6.12 | Complete | Laura Kennedy | COMPLETE |
| 2034 | 1.6.4.1.6.6.2 | Create message templates (DIP, CSS, DTN) |  | 40d | 2024-06-03 A | 2024-07-26 A |  | 100% |  |  |  | 2024-06-03 | 2024-07-26 | 0d |  | finish no earlier than 2024-07-26 | Non-SIT S&A QT Test Team | S&A Qualification |  | 6.12 | Complete | Laura Kennedy | COMPLETE |
| 2035 | 1.6.4.1.6.6.3 | Create Consumption Data Templates |  | 20d | 2024-09-16 A | 2024-10-11 A |  | 100% |  |  |  | 2024-09-16 | 2024-10-11 | 0d |  | finish no earlier than 2024-10-11 | Non-SIT S&A QT Test Team | S&A Qualification |  | 6.12 | Complete | Laura Kennedy | COMPLETE |
| 2036 | 1.6.4.1.6.6.4 | Load Consumption Data |  | 20d | 2024-11-11 A | 2024-12-06 | 2035FS+20d | 85% | 3d |  |  | 2024-11-11 | 2024-12-06 | 0d | 794d |  |  | S&A Qualification |  | 6.12 | Green | Laura Kennedy | GREEN |
| 2037 | 1.6.4.1.6.6.5 | Create Load Shape and Load Shape Total Templates |  | 20d | 2024-09-16 A | 2024-10-11 A |  | 100% |  |  |  | 2024-09-16 | 2024-10-11 | 0d |  | finish no earlier than 2024-10-11 | Non-SIT S&A QT Test Team | S&A Qualification |  | 6.12 | Complete | Laura Kennedy | COMPLETE |
| 2038 | 1.6.4.1.6.6.6 | Load Shape and Load Shape Total Data |  | 20d? | 2024-11-11 A | 2024-12-06 | 2037FS+20d | 85% | 3d? |  |  | 2024-11-11 | 2024-12-06 | 0d | 794d |  |  | S&A Qualification |  | 6.12 | Green | Laura Kennedy | GREEN |
| 2039 | 1.6.4.1.6.6.7 | Create Settlement Report Templates |  | 20d | 2024-09-16 A | 2024-10-11 A |  | 100% |  |  |  | 2024-09-16 | 2024-10-11 | 0d |  | finish no earlier than 2024-10-11 | Non-SIT S&A QT Test Team | S&A Qualification |  | 6.12 | Complete | Laura Kennedy | COMPLETE |
| 2040 | 1.6.4.1.6.6.8 | Load Settlement Report Data |  | 20d? | 2024-11-11 A | 2024-12-06 | 2039FS+20d | 85% | 3d? |  |  | 2024-11-11 | 2024-12-06 | 0d | 794d |  |  | S&A Qualification |  | 6.12 | Green | Laura Kennedy | GREEN |
| 2041 | 1.6.4.1.6.6.9 | Market Domain Data (MDD) For Legacy Systems |  | 25d | 2024-07-29 A | 2024-08-30 A |  | 100% |  |  |  | 2024-07-29 | 2024-08-30 | 0d |  | finish no earlier than 2024-08-30 | Non-SIT S&A QT Test Team | S&A Qualification |  | 6.12 | Complete | Laura Kennedy | COMPLETE |
| 2042 | 1.6.4.1.6.6.10 | **Industry Standing Data (ISD)** |  | 71d | 2024-07-26 | 2024-11-01 |  | 100% |  | 2024-06-10 | 2024-10-25 | 2024-07-26 | 2024-11-01 | 0d |  |  | Non-SIT S&A QT Test Team | S&A Qualification | -742.67 | 6.12 | Overdue Start | Laura Kennedy |  |
| 2043 | 1.6.4.1.6.6.10.1 | Dependant on Receiving ISD Agreed Source Data from Helix |  | 1d | 2024-08-23 A | 2024-08-23 A |  | 100% |  |  |  | 2024-08-23 | 2024-08-23 | 0d |  | finish no earlier than 2024-07-26 | Non-SIT S&A QT Test Team | S&A Qualification |  | 6.12 | Complete | Laura Kennedy | COMPLETE |
| 2044 | 1.6.4.1.6.6.10.2 | Helix Dev Environment migration |  | 6d | 2024-07-29 A | 2024-08-05 A |  | 100% |  |  |  | 2024-07-29 | 2024-08-05 | 0d |  | finish no earlier than 2024-08-05 | Non-SIT S&A QT Test Team | S&A Qualification |  | 6.12 | Complete | Laura Kennedy | COMPLETE |
| 2045 | 1.6.4.1.6.6.10.3 | STGi (UK) migration |  | 5d | 2024-09-09 A | 2024-09-13 A |  | 100% |  |  |  | 2024-09-09 | 2024-09-13 | 0d |  | finish no earlier than 2024-09-13 | Non-SIT S&A QT Test Team | S&A Qualification |  | 6.12 | Complete | Laura Kennedy | COMPLETE |
| 2046 | 1.6.4.1.6.6.10.4 | Maintenance window between cycle 2 and 3 | manual | 1d | 2024-09-20 A | 2024-09-20 A |  | 100% |  |  |  | 2024-09-20 | 2024-09-20 | 0d |  |  | Non-SIT S&A QT Test Team | S&A Qualification |  | 6.12 | Complete | Laura Kennedy | COMPLETE |
| 2047 | 1.6.4.1.6.6.10.5 | First View of Migrated ISD Data |  | 28d | 2024-08-21 A | 2024-09-27 A |  | 100% |  |  |  | 2024-08-21 | 2024-09-27 | 0d |  | finish no earlier than 2024-09-27 | Non-SIT S&A QT Test Team | S&A Qualification |  | 6.12 | Complete | Laura Kennedy | COMPLETE |
| 2048 | 1.6.4.1.6.6.10.6 | Second View of Migrated ISD Data (HXT1 (SIT B) migration) |  | 5d | 2024-09-23 A | 2024-09-27 A |  | 100% |  |  |  | 2024-09-23 | 2024-09-27 | 0d |  | start no earlier than 2024-09-23 | Non-SIT S&A QT Test Team | S&A Qualification |  | 6.12 | Complete | Laura Kennedy | COMPLETE |
| 2049 | 1.6.4.1.6.6.10.7 | Final Cycle 3 Migrated ISD Data |  | 5d | 2024-06-10 A | 2024-06-14 A |  | 100% |  |  |  | 2024-06-10 | 2024-06-14 | 0d |  |  | Non-SIT S&A QT Test Team | S&A Qualification |  | 6.12 | Complete | Laura Kennedy | COMPLETE |
| 2050 | 1.6.4.1.6.6.10.8 | Create ISD Template inc. DIP ID |  | 35d | 2024-06-10 A | 2024-07-26 A |  | 100% |  |  |  | 2024-06-10 | 2024-07-26 | 0d |  |  | Non-SIT S&A QT Test Team | S&A Qualification |  | 6.12 | Complete | Laura Kennedy | COMPLETE |
| 2051 | 1.6.4.1.6.6.10.9 | Publish Qualification ISD | manual | 10d | 2024-10-14 A | 2024-10-25 A |  | 100% |  |  |  | 2024-10-14 | 2024-10-25 | 0d |  |  | Non-SIT S&A QT Test Team | S&A Qualification |  | 6.12 | Complete | Laura Kennedy | COMPLETE |

| ID | WBS | Task | Duration | Start | Finish | Predecessors | Complete | Remaining | Baseline start | Baseline finish | Baseline duration | Total slack | Free slack | Constraint | Responsible | Text9 | Task Status | Update Version | Sched Status | MHHS Resource Name | RAG |
| --- | --- | --- | --- | --- | --- | --- | --- | --- | --- | --- | --- | --- | --- | --- | --- | --- | --- | --- | --- | --- | --- |
| 2052 | 1.6.4.1.6.6.11 | **Industry Standing Data (ISD)** | 71d? | 2024-07-26 A | 2024-11-01 A |  | 100% |  | 2024-07-26 | 2024-11-01 | 0d |  |  |  | Non-SIT S&A QT Test Team | S&A Qualification | -742.67 | 6.12 | Overdue Start | Laura Kennedy |  |
| 2053 | 1.6.4.1.6.6.11.1 | Dependant on Receiving ISD Agreed Source Data from Helix | 1d | 2024-07-26 A | 2024-07-26 A |  | 100% |  | 2024-07-26 | 2024-07-26 | 0d |  |  | start no earlier than 2024-07-26 | Non-SIT S&A QT Test Team | S&A Qualification |  | 6.12 | Complete | Laura Kennedy | COMPLETE |
| 2054 | 1.6.4.1.6.6.11.2 | Helix Dev Environment migration | 6d | 2024-07-29 A | 2024-08-05 A |  | 100% |  | 2024-07-29 | 2024-08-05 | 0d |  |  | finish no earlier than 2024-08-05 | Non-SIT S&A QT Test Team | S&A Qualification |  | 6.12 | Complete | Laura Kennedy | COMPLETE |
| 2055 | 1.6.4.1.6.6.11.3 | STGi (UK) migration | 5d | 2024-09-09 A | 2024-09-13 A |  | 100% |  | 2024-09-09 | 2024-09-13 | 0d |  |  | finish no earlier than 2024-09-13 | Non-SIT S&A QT Test Team | S&A Qualification |  | 6.12 | Complete | Laura Kennedy | COMPLETE |
| 2056 | 1.6.4.1.6.6.11.4 | Maintenance window between cycle 2 and 3 | 1d | 2024-09-20 A | 2024-09-20 A |  | 100% |  | 2024-09-20 | 2024-09-20 | 0d |  |  | finish no earlier than 2024-09-20 | Non-SIT S&A QT Test Team | S&A Qualification |  | 6.12 | Complete | Laura Kennedy | COMPLETE |
| 2057 | 1.6.4.1.6.6.11.5 | First View of Migrated ISD Data | 5d | 2024-09-23 A | 2024-09-27 A | 2053 | 100% |  | 2024-09-23 | 2024-09-27 | 0d |  |  | finish no earlier than 2024-09-27 | Non-SIT S&A QT Test Team | S&A Qualification |  | 6.12 | Complete | Laura Kennedy | COMPLETE |
| 2058 | 1.6.4.1.6.6.11.6 | Second View of Migrated ISD Data (HXT1 (SIT B) migration) | 5d | 2024-09-23 A | 2024-09-27 A |  | 100% |  | 2024-09-23 | 2024-09-27 | 0d |  |  | finish no earlier than 2024-09-27 | Non-SIT S&A QT Test Team | S&A Qualification |  | 6.12 | Complete | Laura Kennedy | COMPLETE |
| 2059 | 1.6.4.1.6.6.11.7 | Final Cycle 3 Migrated ISD Data | 5d | 2024-10-07 A | 2024-10-11 A | 2057 | 100% |  | 2024-10-07 | 2024-10-11 | 0d |  |  | finish no earlier than 2024-10-11 | Non-SIT S&A QT Test Team | S&A Qualification |  | 6.12 | Complete | Laura Kennedy | COMPLETE |
| 2060 | 1.6.4.1.6.6.11.8 | Create ISD Template inc. DIP ID | 35d? | 2024-09-16 A | 2024-11-01 A |  | 100% |  | 2024-09-16 | 2024-11-01 | 0d |  |  | finish no earlier than 2024-11-01 | Non-SIT S&A QT Test Team | S&A Qualification |  | 6.12 | Complete | Laura Kennedy | COMPLETE |
| 2061 | 1.6.4.1.6.6.11.9 | Publish Qualification ISD | 10d? | 2024-10-14 A | 2024-10-25 A |  | 100% |  | 2024-10-14 | 2024-10-25 | 0d |  |  | finish no earlier than 2024-10-25 | Non-SIT S&A QT Test Team | S&A Qualification |  | 6.12 | Complete | Laura Kennedy | COMPLETE |
| 2062 | 1.6.4.1.6.6.12 | **BETA Test Data** | 22d | 2024-11-01 A | 2024-12-02 |  | 81% | 4.23d | 2024-11-01 | 2024-11-15 | 0d | 798d |  |  |  | S&A Qualification | -169.67 | 6.12 | Overdue Start | Laura Kennedy |  |
| 2063 | 1.6.4.1.6.6.12.1 | Provide Example MPAN File | 3d | 2024-11-01 A | 2024-11-05 A | 2096SS | 100% |  | 2024-11-01 | 2024-11-05 | 0d |  |  | finish no earlier than 2024-11-05 |  | S&A Qualification |  | 6.12 | Complete | Laura Kennedy | COMPLETE |
| 2064 | 1.6.4.1.6.6.12.2 | Load Example MPAN File | 6d | 2024-11-06 A | 2024-11-13 A | 2063 | 100% |  | 2024-11-06 | 2024-11-13 | 0d |  |  | finish no earlier than 2024-11-13 |  | S&A Qualification |  | 6.12 | Complete | Laura Kennedy | COMPLETE |
| 2065 | 1.6.4.1.6.6.12.3 | Industry Standing Data (ISD) | 6d | 2024-11-06 A | 2024-11-13 A | 2096SS+3d | 100% |  | 2024-11-06 | 2024-11-13 | 0d |  |  | finish no earlier than 2024-11-13 |  | S&A Qualification |  | 6.12 | Complete | Laura Kennedy | COMPLETE |
| 2066 | 1.6.4.1.6.6.12.4 | Market Domain Data (MDD) | 6d | 2024-11-06 A | 2024-11-13 A | 2096SS+3d | 100% |  | 2024-11-06 | 2024-11-13 | 0d |  |  | finish no earlier than 2024-11-13 |  | S&A Qualification |  | 6.12 | Complete | Laura Kennedy | COMPLETE |
| 2067 | 1.6.4.1.6.6.12.5 | Load ISD / MDD Data | 1d | 2024-11-29 | 2024-11-29 | 2065FS+11d, 2066FS+11d |  |  | 2024-11-14 | 2024-11-14 | 0d | 754d | 0d | start no earlier than 2024-11-14 |  | S&A Qualification | 2.33 | 6.12 | Red | Laura Kennedy | RED |
| 2068 | 1.6.4.1.6.6.12.6 | Create QTC sets and Test MPANs via QTF | 1d | 2024-11-29 | 2024-11-29 | 2064FS+11d |  |  | 2024-11-14 | 2024-11-14 | 0d | 754d | 0d | start no earlier than 2024-11-14 |  | S&A Qualification | 2.33 | 6.12 | Red | Laura Kennedy | RED |
| 2069 | 1.6.4.1.6.6.12.7 | Create QTC sets in ADO via QTF | 1d | 2024-11-29 | 2024-11-29 | 2068SS |  |  | 2024-11-14 | 2024-11-14 | 0d | 799d |  | start no earlier than 2024-11-14 |  | S&A Qualification | 2.33 | 6.12 | Red | Laura Kennedy | RED |
| 2070 | 1.6.4.1.6.6.12.8 | Provide Test MPANs (Suppliers only) allocated to specfic QTC's | 1d | 2024-11-29 | 2024-11-29 | 2067SS |  |  | 2024-11-14 | 2024-11-14 | 0d | 769d | 0d | start no earlier than 2024-11-14 |  | S&A Qualification | 2.33 | 6.12 | Red | Laura Kennedy | RED |
| 2071 | 1.6.4.1.6.6.12.9 | Load Test MPANs | 1d | 2024-12-02 | 2024-12-02 | 2070 |  |  | 2024-11-15 | 2024-11-15 | 0d | 798d |  | start no earlier than 2024-11-15 |  | S&A Qualification | 5.33 | 6.12 | Red | Laura Kennedy | RED |
| 2072 | 1.6.4.1.6.6.13 | **Wave 1 Test Data** | 46d | 2025-05-12 | 2025-07-15 | 2068SS |  |  | 2025-05-12 | 2025-07-15 | 0d |  |  |  | Non-SIT S&A QT Test Team | S&A Qualification | -168.67 | 6.12 | Overdue Start | Laura Kennedy |  |
| 2073 | 1.6.4.1.6.6.13.1 | Test Data Request + Templates Completed | 16d | 2025-04-21 | 2025-05-12 | 2067SS |  |  | 2025-04-21 | 2025-05-12 | 0d | 653d | 6d | finish no earlier than 2025-05-12 | Non-SIT S&A QT Test Team | S&A Qualification | 145.33 | 6.12 | Green | Laura Kennedy | GREEN |
| 2074 | 1.6.4.1.6.6.13.2 | Test Data Generated | 10d | 2025-05-21 | 2025-06-03 | 2070, 2073 |  |  | 2025-05-21 | 2025-06-03 | 0d | 647d | 0d | finish no earlier than 2025-06-03 | Non-SIT S&A QT Test Team | S&A Qualification | 175.33 | 6.12 | Green | Laura Kennedy | GREEN |
| 2075 | 1.6.4.1.6.6.13.3 | Test Data Loaded into QP Systems | 20d | 2025-06-04 | 2025-07-01 | 2074 |  |  | 2025-06-04 | 2025-07-01 | 0d | 647d |  | finish no earlier than 2025-06-17 | Non-SIT S&A QT Test Team | S&A Qualification | 189.33 | 6.12 | Green | Laura Kennedy | GREEN |
| 2076 | 1.6.4.1.6.6.13.4 | Test Data Loaded into QTF + ADO | 19d | 2025-06-04 | 2025-06-30 | 2074 |  |  | 2025-06-04 | 2025-06-30 | 0d | 648d |  | finish no earlier than 2025-06-17 | Non-SIT S&A QT Test Team | S&A Qualification | 189.33 | 6.12 | Green | Laura Kennedy | GREEN |

Notes:
- 2067: 26/11/24 - Issue with ISD that's affecting LDSO / Beta Testing, these dates have been extended to reflected this.
- 2068: 26/11/24 - Issue with ISD that's affecting LDSO / Beta Testing, these dates have been extended to reflected this.
- 2069: 26/11/24 - Issue with ISD that's affecting LDSO / Beta Testing, these dates have been extended to reflected this.
- 2070: 26/11/24 - Issue with ISD that's affecting LDSO / Beta Testing, these dates have been extended to reflected this.
- 2071: 26/11/24 - Issue with ISD that's affecting LDSO / Beta Testing, these dates have been extended to reflected this.

| ID | WBS | Task | Type | Duration | Start | Finish | Predecessors | Complete | Remaining | Baseline start | Baseline finish | Baseline duration | Total slack | Free slack | Constraint | Baseline cost | Responsible | Text9 | Task Status | Update Version | Sched Status | MHHS Resource Name | RAG | Milestone ID | Involved | Text29 |
| --- | --- | --- | --- | --- | --- | --- | --- | --- | --- | --- | --- | --- | --- | --- | --- | --- | --- | --- | --- | --- | --- | --- | --- | --- | --- | --- |
| 2077 | 1.6.4.1.6.6.14 | **Wave 2 Test Data** |  | 42d | 2025-07-07 | 2025-09-03 |  |  |  | 2025-07-07 | 2025-09-03 | 0d |  |  |  |  | Non-SIT S&A QT Test Team | S&A Qualification | -168.67 | 6.12 | Overdue Start | Laura Kennedy |  |  |  |  |
| 2078 | 1.6.4.1.6.6.14.1 | Test Data Request + Templates Completed |  | 16d | 2025-06-16 | 2025-07-07 |  |  |  | 2025-06-16 | 2025-07-07 | 0d | 617d | 6d | finish no earlier than 2025-07-07 |  | Non-SIT S&A QT Test Team | S&A Qualification | 201.33 | 6.12 | Green | Laura Kennedy | GREEN |  |  |  |
| 2079 | 1.6.4.1.6.6.14.2 | Test Data Generated |  | 10d | 2025-07-16 | 2025-07-29 | 2078 |  |  | 2025-07-16 | 2025-07-29 | 0d | 611d | 0d | finish no earlier than 2025-07-29 |  | Non-SIT S&A QT Test Team | S&A Qualification | 231.33 | 6.12 | Green | Laura Kennedy | GREEN |  |  |  |
| 2080 | 1.6.4.1.6.6.14.3 | Test Data Loaded into QP Systems |  | 16d | 2025-07-30 | 2025-08-20 | 2079 |  |  | 2025-07-30 | 2025-08-20 | 0d | 611d |  | finish no earlier than 2025-08-12 |  | Non-SIT S&A QT Test Team | S&A Qualification | 245.33 | 6.12 | Green | Laura Kennedy | GREEN |  |  |  |
| 2081 | 1.6.4.1.6.6.14.4 | Test Data Loaded into QTF + ADO |  | 16d | 2025-07-30 | 2025-08-20 | 2079 |  |  | 2025-07-30 | 2025-08-20 | 0d | 611d |  | finish no earlier than 2025-08-12 |  | Non-SIT S&A QT Test Team | S&A Qualification | 245.33 | 6.12 | Green | Laura Kennedy | GREEN |  |  |  |
| 2082 | 1.6.4.1.6.6.15 | **Wave 3 Test Data** |  | 45d | 2025-09-08 | 2025-11-10 |  |  |  | 2025-09-08 | 2025-11-10 | 0d |  |  |  |  | Non-SIT S&A QT Test Team | S&A Qualification | -168.67 | 6.12 | Overdue Start | Laura Kennedy |  |  |  |  |
| 2083 | 1.6.4.1.6.6.15.1 | Test Data Request + Templates Completed |  | 15d | 2025-08-19 | 2025-09-08 |  |  |  | 2025-08-19 | 2025-09-08 | 0d | 568d | 5d | finish no earlier than 2025-09-08 |  | Non-SIT S&A QT Test Team | S&A Qualification | 265.33 | 6.12 | Green | Laura Kennedy | GREEN |  |  |  |
| 2084 | 1.6.4.1.6.6.15.2 | Test Data Generated |  | 10d | 2025-09-16 | 2025-09-29 | 2083 |  |  | 2025-09-16 | 2025-09-29 | 0d | 563d | 0d | finish no earlier than 2025-09-29 |  | Non-SIT S&A QT Test Team | S&A Qualification | 293.33 | 6.12 | Green | Laura Kennedy | GREEN |  |  |  |
| 2085 | 1.6.4.1.6.6.15.3 | Test Data Loaded into QP Systems |  | 20d | 2025-09-30 | 2025-10-27 | 2084 |  |  | 2025-09-30 | 2025-10-27 | 0d | 563d |  | finish no earlier than 2025-10-13 |  | Non-SIT S&A QT Test Team | S&A Qualification | 307.33 | 6.12 | Green | Laura Kennedy | GREEN |  |  |  |
| 2086 | 1.6.4.1.6.6.15.4 | Test Data Loaded into QTF + ADO |  | 20d | 2025-09-30 | 2025-10-27 | 2084 |  |  | 2025-09-30 | 2025-10-27 | 0d | 563d |  | finish no earlier than 2025-10-13 |  | Non-SIT S&A QT Test Team | S&A Qualification | 307.33 | 6.12 | Green | Laura Kennedy | GREEN |  |  |  |
| 2087 | 1.6.4.1.6.6.16 | **Wave 4 Test Data** |  | 45d | 2025-11-06 | 2026-01-08 |  |  |  | 2025-11-06 | 2026-01-08 | 0d |  |  |  |  | Non-SIT S&A QT Test Team | S&A Qualification | -168.67 | 6.12 | Overdue Start | Laura Kennedy |  |  |  |  |
| 2088 | 1.6.4.1.6.6.16.1 | Test Data Request + Templates Completed |  | 15d | 2025-10-17 | 2025-11-06 |  |  |  | 2025-10-17 | 2025-11-06 | 0d | 525d | 5d | finish no earlier than 2025-11-06 |  | Non-SIT S&A QT Test Team | S&A Qualification | 324.33 | 6.12 | Green | Laura Kennedy | GREEN |  |  |  |
| 2089 | 1.6.4.1.6.6.16.2 | Test Data Generated |  | 10d | 2025-11-14 | 2025-11-27 | 2088 |  |  | 2025-11-14 | 2025-11-27 | 0d | 520d | 0d | finish no earlier than 2025-11-27 |  | Non-SIT S&A QT Test Team | S&A Qualification | 352.33 | 6.12 | Green | Laura Kennedy | GREEN |  |  |  |
| 2090 | 1.6.4.1.6.6.16.3 | Test Data Loaded into QP Systems |  | 20d | 2025-11-28 | 2025-12-25 | 2089 |  |  | 2025-11-28 | 2025-12-25 | 0d | 520d |  | finish no earlier than 2025-12-11 |  | Non-SIT S&A QT Test Team | S&A Qualification | 366.33 | 6.12 | Green | Laura Kennedy | GREEN |  |  |  |
| 2091 | 1.6.4.1.6.6.16.4 | Test Data Loaded into QTF + ADO |  | 20d | 2025-11-28 | 2025-12-25 | 2089 |  |  | 2025-11-28 | 2025-12-25 | 0d | 520d |  | finish no earlier than 2025-12-11 |  | Non-SIT S&A QT Test Team | S&A Qualification | 366.33 | 6.12 | Green | Laura Kennedy | GREEN |  |  |  |
| 2092 | 1.6.4.1.6.6.17 | **Governance** |  | 195d? | 2024-07-01 A | 2025-03-28 |  | 7% | 182.09d? | 2024-07-01 | 2024-12-20 | 0d | 714d |  |  |  | Non-SIT S&A QT Test Team | S&A Qualification | -168.67 | 6.12 | Overdue Start | Laura Kennedy | RED |  |  |  |
| 2093 | 1.6.4.1.6.6.17.1 | Onboarding Strategy and Develop Training Requirements & Materials Inc. Day in the Life |  | 110d | 2024-07-01 | 2024-11-29 | 1971 |  |  | 2024-07-01 | 2024-11-29 | 0d | 784d | 0d |  |  | Non-SIT S&A QT Test Team | S&A Qualification | -148.67 | 6.12 | Overdue Start | Laura Kennedy | GREEN |  |  |  |
| 2094 | 1.6.4.1.6.6.17.2 | Design Approach & Set-Up ADO Tool for Test & Defect Management Tool |  | 20d | 2024-07-01 A | 2024-07-26 A | 2093SS | 100% |  | 2024-07-01 | 2024-07-26 | 0d |  |  |  |  | Non-SIT S&A QT Test Team | S&A Qualification |  | 6.12 | Complete | Laura Kennedy | COMPLETE |  |  |  |
| 2095 | 1.6.4.1.6.6.17.3 | Knowledge Transfer, Training, Demonstrations, Documentation, Governance |  | 78d | 2024-08-30 | 2024-12-17 | 2093SS+44d |  |  | 2024-08-30 | 2024-12-17 | 0d | 784d | 0d |  |  | Non-SIT S&A QT Test Team | S&A Qualification | -88.67 | 6.12 | Overdue Start | Laura Kennedy | GREEN |  |  |  |
| 2096 | 1.6.4.1.6.6.17.4 | BETA Testing |  | 36d | 2024-11-01 | 2024-12-20 |  |  |  | 2024-11-01 | 2024-12-20 | 0d | 714d | 0d | finish no earlier than 2024-12-20 |  | Non-SIT S&A QT Test Team | S&A Qualification | -25.67 | 6.12 | Green | Laura Kennedy | GREEN |  |  |  |
| 2097 | 1.6.4.1.6.6.17.5 | BETA Testing 2 |  | 58d? | 2025-01-08 | 2025-03-28 | 2096FS+12d |  |  |  |  |  | 714d |  |  |  |  | S&A Qualification | 42.33 | 6.13 | No BL |  | GREEN |  |  |  |
| 2098 | 1.6.4.1.6.6.18 | Qualification Testing Framework Readiness Confirmed | milestone | 0d | 2024-12-20 | 2024-12-20 | 2095FS+3d, 2096 |  |  | 2024-12-20 | 2024-12-20 | 0d | 784d |  |  |  | Non-SIT S&A QT Test Team | S&A Qualification | 23.71 | 6.12 | Green | Laura Kennedy | GREEN |  |  |  |
| 2099 | 1.6.4.1.6.6.19 | Qualification Testing Wave Readiness Confirmed | milestone | 0d | 2024-05-27 | 2024-05-27 |  |  |  | 2024-05-27 | 2024-05-27 |  | 331d | 325d |  |  |  | S&A Qualification | -183.67 | 6.13 | Overdue Start |  | RED | T2-QU-1100 |  |  |
| 2100 | 1.6.4.1.7 | **Wave Allocation** |  | 129d | 2024-01-02 A | 2024-06-28 A |  | 100% |  | 2024-01-02 | 2024-06-28 | 128d |  |  |  | -0 | N/A | S&A Qualification | -133.67 | 5.24 |  | N/A |  |  | N/A |  |
| 2101 | 1.6.4.1.7.1 | Draft Pre-Qualification Submission (PQS) document |  | 20d | 2024-01-02 A | 2024-01-29 A |  | 100% |  | 2024-01-02 | 2024-01-29 | 20d |  |  | finish no earlier than 2024-01-26 |  | Code Bodies | S&A Qualification |  | 5.24 | Complete | Laura Kennedy | COMPLETE |  | Code Bodies |  |
| 2102 | 1.6.4.1.7.2 | Publish PQS document |  | 1d | 2024-01-31 A | 2024-01-31 A |  | 100% |  | 2024-01-31 | 2024-01-31 | 1d |  |  | start no earlier than 2024-01-31 |  | Code Bodies | S&A Qualification |  | 5.24 | Complete | Laura Kennedy | COMPLETE |  | Code Bodies |  |
| 2103 | 1.6.4.1.7.3 | PQS Submission window |  | 60d | 2024-02-05 A | 2024-04-26 A |  | 100% |  | 2024-02-05 | 2024-04-26 | 60d |  |  | start no earlier than 2024-02-05 |  | Participants | S&A Qualification |  | 5.24 | Complete | Laura Kennedy | COMPLETE |  | Participants |  |
| 2104 | 1.6.4.1.7.4 | Pre-Qualification Submission and PIT Test Plan Deadline for Submission​ | milestone | 0d | 2024-04-26 A | 2024-04-26 A | 2103 | 100% |  | 2024-04-26 | 2024-04-26 | 0d |  |  |  |  | Participants | S&A Qualification |  | 5.25 | Complete | Laura Kennedy | COMPLETE | T3-QU-0118 | Participants | QAG |
| 2105 | 1.6.4.1.7.5 | PQS Review by Code Bodies |  | 25d | 2024-04-29 A | 2024-05-31 A | 2103, 2104 | 100% |  | 2024-04-29 | 2024-05-31 | 25d |  |  |  |  | Code Bodies | S&A Qualification |  | 5.24 | Complete | Laura Kennedy | COMPLETE |  | Code Bodies |  |
| 2106 | 1.6.4.1.7.6 | Draft Wave Allocations |  | 15d | 2024-06-03 A | 2024-06-21 A | 2105 | 100% |  | 2024-06-03 | 2024-06-21 | 15d |  |  |  |  | Code Bodies | S&A Qualification |  | 5.24 | Complete | Laura Kennedy | COMPLETE |  | Code Bodies |  |
| 2107 | 1.6.4.1.7.7 | Confirmation of participant Qualification Wave allocation | milestone | 0d | 2024-06-28 A | 2024-06-28 A | 2106FS+5d | 100% |  | 2024-06-28 | 2024-06-28 | 0d |  |  |  |  | Code Bodies | S&A Qualification |  | 5.28 | Complete | Laura Kennedy | COMPLETE | T3-QU-0012 | Code Bodies | QAG |

Notes:
- 2097: 26/11/24 - New activity added to reflect the approach being taken to BETA testing.
- 2099: 26/11/24 - New milestone proposed to reflect the conlcusion of the activity the Programme needs to complete to be ready for Testing Wave start. This will go to QAG for formal approval.

| ID | WBS | Task | Type | Duration | Start | Finish | Predecessors | Baseline start | Baseline finish | Baseline duration | Total slack | Free slack | Constraint | Baseline cost | Responsible | Involved | Text9 | Task Status | Update Version | MHHS Resource Name | Sched Status | RAG | Milestone ID | Text29 |
| --- | --- | --- | --- | --- | --- | --- | --- | --- | --- | --- | --- | --- | --- | --- | --- | --- | --- | --- | --- | --- | --- | --- | --- | --- |
| 2108 | 1.6.4.2 | **Qualification Wave 1** |  | 248d | 2025-05-05 | 2026-04-15 |  | 2025-03-24 | 2026-04-10 | 229d | 5d |  |  | -0 | N/A | N/A | S&A Qualification | -133.67 | 6.1 | N/A |  |  |  |  |
| 2109 | 1.6.4.2.1 | **Qualification Wave 1 QAD Prep** |  | 80d | 2025-05-05 | 2025-08-22 |  | 2025-03-24 | 2025-07-11 | 80d | 6d |  |  | -0 | N/A | N/A | S&A Qualification | -152.67 | 6.1 | N/A |  |  |  |  |
| 2110 | 1.6.4.2.1.1 | Initial QAD Submission window opens | milestone | 0d | 2025-05-05 | 2025-05-05 | 2107, 1892FS+11d | 2025-05-05 | 2025-05-05 | 0d | 6d | 0d | start no earlier than 2025-03-24 |  | Participants | Participants | S&A Qualification | 159.71 | 6.1 | Laura Kennedy | Green | GREEN |  |  |
| 2111 | 1.6.4.2.1.2 | Qualification Wave 1 Participants Submit Initial QAD |  | 50d | 2025-05-05 | 2025-07-11 | 2110FS-1d | 2025-05-05 | 2025-07-11 | 50d | 6d | 0d |  |  | Participants | Participants | S&A Qualification | 159.33 | 6.1 | Laura Kennedy | Green | GREEN |  |  |
| 2112 | 1.6.4.2.1.3 | Qualification Wave 1 Participants have submitted their initial QAD | milestone | 0d | 2025-07-14 | 2025-07-14 | 2111FS+1d | 2025-07-14 | 2025-07-14 | 0d | 6d | 0d |  |  | Participants | Participants | S&A Qualification | 229.71 | 6.1 | Laura Kennedy | Green | GREEN | T3-QU-0094 | QAG |
| 2113 | 1.6.4.2.1.4 | Code Bodies review of Wave 1 Participants Initial QAD |  | 30d | 2025-07-14 | 2025-08-22 | 2111FS-1d, 2112FS-1d | 2025-07-14 | 2025-08-22 | 30d | 6d | 0d |  |  | Code Bodies | Code Bodies | S&A Qualification | 229.33 | 6.1 | Laura Kennedy | Green | GREEN |  |  |
| 2114 | 1.6.4.2.1.5 | Completion of Code Bodies review of Initial QAD | milestone | 0d | 2025-08-22 | 2025-08-22 | 2113 | 2025-08-22 | 2025-08-22 | 0d | 6d | 0d |  |  | Code Bodies | Code Bodies | S&A Qualification | 268.71 | 6.1 | Laura Kennedy | Green | GREEN |  |  |
| 2115 | 1.6.4.2.2 | **Qualification Wave 1 Test Prep** |  | 60d | 2025-05-26 | 2025-08-15 |  | 2025-04-14 | 2025-07-04 | 60d | 11d |  |  | -0 | N/A | N/A | S&A Qualification | -555.67 | 6.11 | N/A |  |  |  |  |
| 2116 | 1.6.4.2.2.1 | Confirmation from Qualification Wave 1 Participants that DIP onboarding has commenced | milestone | 0d | 2025-05-26 | 2025-05-26 |  | 2025-05-26 | 2025-05-26 | 0d | 31d | 0d | start no earlier than 2025-05-26 |  | Participants | Participants | S&A Qualification | 180.33 | 6.11 | Laura Kennedy | Green | GREEN | T3-QU-0017 | QAG |
| 2117 | 1.6.4.2.2.2 | Qualification Wave 1 Participants DIP Onboarding Window |  | 35d | 2025-05-26 | 2025-07-11 | 2116 | 2025-05-26 | 2025-07-11 | 35d | 31d | 0d |  |  | Participants | Participants | S&A Qualification | 180.33 | 6.11 | Laura Kennedy | Green | GREEN |  |  |
| 2118 | 1.6.4.2.2.3 | Confirmation from Qualification Wave 1 Participants that DIP onboarding has completed | milestone | 0d | 2025-07-11 | 2025-07-11 | 2117 | 2025-07-11 | 2025-07-11 | 0d | 31d | 25d |  |  | Participants | Participants | S&A Qualification | 226.71 | 6.11 | Laura Kennedy | Green | GREEN | T3-TE-0017 |  |
| 2119 | 1.6.4.2.2.4 | Qualification Wave 1 Participants' to provide status of PIT completion and submit QT Test Plan | milestone | 0d | 2025-06-13 | 2025-06-13 |  | 2025-06-16 | 2025-06-16 | 0d | 37d | 0d | start no earlier than 2025-06-13 |  | Participants | Participants | S&A Qualification | 198.33 | 6.11 | Laura Kennedy | Green | GREEN | T3-QU-0095 | QAG |
| 2120 | 1.6.4.2.2.5 | Review of Participants' PIT Status and QT Test Plan |  | 15d | 2025-06-13 | 2025-07-03 | 2119 | 2025-06-16 | 2025-07-04 | 15d | 37d | 0d |  |  | Code Bodies, Non-SIT S&A QT Test Team | Code Bodies, Non-SIT S&A QT Test Team | S&A Qualification | 198.33 | 6.11 | Laura Kennedy | Green | GREEN |  |  |
| 2121 | 1.6.4.2.2.6 | Qualification Test Plans for Wave 1 Participants approved | milestone | 0d | 2025-07-03 | 2025-07-03 | 2120 | 2025-07-04 | 2025-07-04 | 0d | 37d | 31d |  |  | Non-SIT S&A QT Test Team | Non-SIT S&A QT Test Team | S&A Qualification | 218.71 | 6.11 | Laura Kennedy | Green | GREEN | T3-QU-0016 | QAG |
| 2122 | 1.6.4.2.2.7 | Qualification Wave 1 Participants have submitted PIT Test Completion Report and evidence for QT Entry | milestone | 0d | 2025-07-14 | 2025-07-14 |  | 2025-07-14 | 2025-07-14 | 0d | 6d | 0d | start no earlier than 2025-07-14 |  | Participants | Participants | S&A Qualification | 229.33 | 6.11 | Laura Kennedy | Green | GREEN | T3-QU-0096 | QAG |
| 2123 | 1.6.4.2.2.8 | Review of Participants PIT Test Completion Report |  | 25d | 2025-07-14 | 2025-08-15 | 2122 | 2025-07-14 | 2025-08-15 | 25d | 6d | 0d |  |  | Code Bodies, Non-SIT S&A QT Test Team | Code Bodies, Non-SIT S&A QT Test Team | S&A Qualification | 229.33 | 6.11 | Laura Kennedy | Green | GREEN |  |  |
| 2124 | 1.6.4.2.2.9 | Onboarding to QTF & ADO |  | 25d | 2025-07-14 | 2025-08-15 | 2123SS | 2025-07-14 | 2025-08-15 | 25d | 11d | 6d |  |  | Code Bodies, Non-SIT S&A QT Test Team | Code Bodies, Non-SIT S&A QT Test Team | S&A Qualification | 229.33 | 6.11 | Laura Kennedy | Green | GREEN |  |  |
| 2125 | 1.6.4.2.3 | **Qualification Wave 1 QT Execution** |  | 105d | 2025-08-18 | 2026-01-09 |  | 2025-08-18 | 2026-01-09 | 100d | 6d |  |  | -0 | N/A | N/A | S&A Qualification | -152.67 | 6.1 | N/A |  |  |  |  |
| 2126 | 1.6.4.2.3.1 | Review Entry Criteria Evidence for each Wave 1 Participant |  | 5d | 2025-08-18 | 2025-08-22 | 2114FF, 2118, 2121, 2123 | 2025-08-18 | 2025-08-22 | 5d | 6d | 0d |  |  | Non-SIT S&A QT Test Team | Non-SIT S&A QT Test Team | S&A Qualification | 264.33 | 6.1 | Laura Kennedy | Green | GREEN |  |  |
| 2127 | 1.6.4.2.3.2 | Qualification Wave 1 Participant Test Readiness Confirmed | milestone | 0d | 2025-08-22 | 2025-08-22 | 2113, 2114, 2126FF, 2099 | 2025-08-22 | 2025-08-22 | 0d | 6d | 1d |  |  | Non-SIT S&A QT Test Team | Non-SIT S&A QT Test Team | S&A Qualification | 268.71 | 6.1 | Laura Kennedy | Green | GREEN | T3-QU-0027 | QAG |
| 2128 | 1.6.4.2.3.3 | Qualification Wave 1 QT Execution Start | milestone | 0d | 2025-08-25 | 2025-08-25 | 2127, 2124, 1500FS+6d | 2025-08-25 | 2025-08-25 | 0d | 5d | 0d | start no earlier than 2025-07-14 |  | Participants | Participants | S&A Qualification | 271.71 | 6.1 | Laura Kennedy | Green | GREEN | T3-QU-0028 | QAG |
| 2129 | 1.6.4.2.3.4 | Qualification Wave 1 QT Execution Window |  | 100d | 2025-08-25 | 2026-01-09 | 2128FS-1d | 2025-08-25 | 2026-01-09 | 95d | 10d | 0d |  |  | Participants | Participants | S&A Qualification | 271.33 | 6.1 | Laura Kennedy | Green | GREEN |  |  |
| 2130 | 1.6.4.2.3.5 | Qualification Wave 1 QT Projected Execution End | milestone | 0d | 2026-01-09 | 2026-01-09 | 2129 | 2026-01-09 | 2026-01-09 | 0d | 10d | 5d |  |  | Participants | Participants | S&A Qualification | 408.71 | 6.1 | Laura Kennedy | Green | GREEN | T3-QU-0054 | QAG |
| 2131 | 1.6.4.2.4 | **Qualification Wave 1 Exit** |  | 168d | 2025-08-25 | 2026-04-15 |  | 2025-08-25 | 2026-04-15 | 149d? | 5d |  |  | -0 | N/A | N/A | S&A Qualification | -152.67 | 6.1 | N/A |  |  |  |  |
| 2132 | 1.6.4.2.4.1 | Final QAD Submission window opens | milestone | 0d | 2025-08-25 | 2025-08-25 | 2128 | 2025-08-25 | 2025-08-25 | 0d | 5d | 0d |  |  | Participants | Participants | S&A Qualification | 271.71 | 6.1 | Laura Kennedy | Green | GREEN |  |  |
| 2133 | 1.6.4.2.4.2 | Qualification Wave 1 Participants submit their Final QAD |  | 105d | 2025-08-25 | 2026-01-16 | 2132FS-1d | 2025-08-25 | 2026-01-16 | 100d | 5d | 0d |  |  | Participants | Participants | S&A Qualification | 271.33 | 6.1 | Laura Kennedy | Green | GREEN |  |  |
| 2134 | 1.6.4.2.4.3 | Qualification Wave 1 Participants have submitted their final QAD | milestone | 0d | 2026-01-16 | 2026-01-16 | 2133, 2130 | 2026-01-16 | 2026-01-16 | 0d | 5d | 0d |  |  | Participants | Participants | S&A Qualification | 415.71 | 6.1 | Laura Kennedy | Green | GREEN | T3-QU-0097 | QAG |
| 2135 | 1.6.4.2.4.4 | Completion of Code Bodies review of Final QAD |  | 35d | 2026-01-19 | 2026-03-06 | 2133, 2134 | 2026-01-19 | 2026-03-06 | 20d | 5d | 0d |  |  | Code Bodies | Code Bodies | S&A Qualification | 418.33 | 6.1 | Laura Kennedy | Green | GREEN |  |  |
| 2136 | 1.6.4.2.4.5 | QAD Sign Off deadline |  | 1d | 2026-03-20 | 2026-03-20 | 2135FS+9d | 2026-03-20 | 2026-03-20 | 1d | 5d | 0d |  |  | Participants | Participants | S&A Qualification | 478.33 | 6.1 | Laura Kennedy | Green | GREEN |  |  |
| 2137 | 1.6.4.2.4.6 | Qualification Wave 1 Participants Qualification approved by BSC PAB and REC Manager | milestone | 0d | 2026-04-15 | 2026-04-15 | 2136FS+18d | 2026-04-15 | 2026-04-15 | 0d | 5d | 0d |  |  | Code Bodies | Code Bodies | S&A Qualification | 504.71 | 6.1 | Laura Kennedy | Green | GREEN | T2-QU-0150 | QAG |

Notes:
- 2118: 26/11/24 - There was duplicative activity in the SIT plan, which we propose to remove. We also propose to move the milestone ID associated with that activity to this task, this is going to QAG for approval.

| ID | WBS | Task | Type | Duration | Start | Finish | Predecessors | Baseline start | Baseline finish | Baseline duration | Total slack | Free slack | Constraint | Baseline cost | Responsible | Involved | Text9 | Task Status | Update Version | MHHS Resource Name | Sched Status | RAG | Milestone ID | Text29 |
| --- | --- | --- | --- | --- | --- | --- | --- | --- | --- | --- | --- | --- | --- | --- | --- | --- | --- | --- | --- | --- | --- | --- | --- | --- |
| 2138 | 1.6.4.3 | **Qualification Wave 2** |  | 254d | 2025-06-09 | 2026-05-28 |  | 2025-06-09 | 2026-05-28 | 249d | 5d |  |  | -0 | N/A | N/A | S&A Qualification | -133.67 | 6.1 | N/A |  |  |  |  |
| 2139 | 1.6.4.3.1 | **Qualification Wave 2 QAD Prep** |  | 95d | 2025-06-09 | 2025-10-17 |  | 2025-06-09 | 2025-10-17 | 96d | 5d |  |  | -0 | N/A | N/A | S&A Qualification | -154.67 | 6.1 | N/A |  |  |  |  |
| 2140 | 1.6.4.3.1.1 | Initial QAD Submission window opens | milestone | 0d | 2025-06-09 | 2025-06-09 | 1893FS+151d | 2025-06-09 | 2025-06-09 | 0d | 5d | 0d |  |  | Participants | Participants | S&A Qualification | 194.71 | 6.1 | Laura Kennedy | Green | GREEN |  |  |
| 2141 | 1.6.4.3.1.2 | Qualification Wave 2 Participants Submit Initial QAD |  | 70d | 2025-06-09 | 2025-09-12 | 2140FS-1d | 2025-06-09 | 2025-09-12 | 70d | 5d | 0d |  |  | Participants | Participants | S&A Qualification | 194.33 | 6.1 | Laura Kennedy | Green | GREEN |  |  |
| 2142 | 1.6.4.3.1.3 | Qualification Wave 2 Participants have submitted their initial QAD | milestone | 0d | 2025-09-12 | 2025-09-12 | 2141 | 2025-09-12 | 2025-09-12 | 0d | 5d | 0d |  |  | Participants | Participants | S&A Qualification | 289.71 | 6.1 | Laura Kennedy | Green | GREEN | T3-QU-0098 | QAG |
| 2143 | 1.6.4.3.1.4 | Code Bodies review of Wave 2 Participants' Initial QAD |  | 25d | 2025-09-15 | 2025-10-17 | 2142 | 2025-09-15 | 2025-10-17 | 26d | 5d | 0d |  |  | Code Bodies | Code Bodies | S&A Qualification | 292.33 | 6.1 | Laura Kennedy | Green | GREEN |  |  |
| 2144 | 1.6.4.3.1.5 | Completion of Code Bodies review of Initial QAD | milestone | 0d | 2025-10-17 | 2025-10-17 | 2143 | 2025-10-17 | 2025-10-17 | 0d | 5d | 0d |  |  | Code Bodies | Code Bodies | S&A Qualification | 324.71 | 6.1 | Laura Kennedy | Green | GREEN |  |  |
| 2145 | 1.6.4.3.2 | **Qualification Wave 2 Test Prep** |  | 60d | 2025-07-21 | 2025-10-10 |  | 2025-07-21 | 2025-10-10 | 60d | 11d |  |  | -0 | N/A | N/A | S&A Qualification | -555.67 | 6.11 | N/A |  |  |  |  |
| 2146 | 1.6.4.3.2.1 | Confirmation from Qualification Wave 2 Participants that DIP Onboarding has commenced | milestone | 0d | 2025-07-21 | 2025-07-21 |  | 2025-07-21 | 2025-07-21 | 0d | 30d | 0d | start no earlier than 2025-07-21 |  | Participants | Participants | S&A Qualification | 236.33 | 6.11 | Laura Kennedy | Green | GREEN | T3-QU-0021 | QAG |
| 2147 | 1.6.4.3.2.2 | Qualification Wave 2 Participants DIP Onboarding Window |  | 35d | 2025-07-21 | 2025-09-05 | 2146 | 2025-07-21 | 2025-09-05 | 40d | 30d | 0d |  |  | Participants | Participants | S&A Qualification | 236.33 | 6.11 | Laura Kennedy | Green | GREEN |  |  |
| 2148 | 1.6.4.3.2.3 | Confirmation from Qualificiation Wave 2 Participants that DIP onboarding has completed | milestone | 0d | 2025-09-05 | 2025-09-05 | 2147 | 2025-09-05 | 2025-09-05 | 0d | 30d | 25d |  |  | Participants | Participants | S&A Qualification | 282.71 | 6.11 | Laura Kennedy | Green | GREEN |  |  |
| 2149 | 1.6.4.3.2.4 | Qualification Wave 2 Participants' to provide status of PIT completion and submit QT Test Plan | milestone | 0d | 2025-08-18 | 2025-08-18 |  | 2025-08-18 | 2025-08-18 | 0d | 30d | 0d | start no earlier than 2025-08-18 |  | Participants | Participants | S&A Qualification | 264.33 | 6.11 | Laura Kennedy | Green | GREEN | T3-QU-0099 | QAG |
| 2150 | 1.6.4.3.2.5 | Review of Participants' PIT Status and QT Test Plan |  | 15d | 2025-08-18 | 2025-09-05 | 2149 | 2025-08-18 | 2025-09-05 | 15d | 30d | 0d | start no earlier than 2025-07-07 |  | Code Bodies, Non-SIT S&A QT Test Team | Code Bodies, Non-SIT S&A QT Test Team | S&A Qualification | 264.33 | 6.11 | Laura Kennedy | Green | GREEN |  |  |
| 2151 | 1.6.4.3.2.6 | Qualification Test Plans for Wave 2 Participants approved | milestone | 0d | 2025-09-05 | 2025-09-05 | 2150 | 2025-09-05 | 2025-09-05 | 0d | 30d | 25d | start no earlier than 2025-07-25 |  | Non-SIT S&A QT Test Team | Non-SIT S&A QT Test Team | S&A Qualification | 282.71 | 6.11 | Laura Kennedy | Green | GREEN | T3-QU-0020 | QAG |
| 2152 | 1.6.4.3.2.7 | Qualification Wave 2 Participants have submitted PIT Test Completion Report and evidence for QT entry | milestone | 0d | 2025-09-08 | 2025-09-08 |  | 2025-09-08 | 2025-09-08 | 0d | 5d | 0d | start no earlier than 2025-09-08 |  | Participants | Participants | S&A Qualification | 285.33 | 6.11 | Laura Kennedy | Green | GREEN | T3-QU-0100 | QAG |
| 2153 | 1.6.4.3.2.8 | Review of Participants' PIT Test Completion Report |  | 25d | 2025-09-08 | 2025-10-10 | 2152 | 2025-09-08 | 2025-10-10 | 25d | 5d | 0d |  |  | Code Bodies, Non-SIT S&A QT Test Team | Code Bodies, Non-SIT S&A QT Test Team | S&A Qualification | 285.33 | 6.11 | Laura Kennedy | Green | GREEN |  |  |
| 2154 | 1.6.4.3.2.9 | Onboarding to QTF & ADO |  | 25d | 2025-09-08 | 2025-10-10 | 2153SS | 2025-09-08 | 2025-10-10 | 25d | 11d | 6d |  |  | Code Bodies, Non-SIT S&A QT Test Team | Code Bodies, Non-SIT S&A QT Test Team | S&A Qualification | 285.33 | 6.11 | Laura Kennedy | Green | GREEN |  |  |
| 2155 | 1.6.4.3.3 | **Qualification Wave 2 QT Execution** |  | 100d | 2025-10-13 | 2026-02-27 |  | 2025-10-13 | 2026-02-27 | 99d | 5d |  |  | -0 | N/A | N/A | S&A Qualification | -154.67 | 6.1 | N/A |  |  |  |  |
| 2156 | 1.6.4.3.3.1 | Review Entry Criteria Evidence for each Wave 2 Participant |  | 5d | 2025-10-13 | 2025-10-17 | 2144FF, 2148, 2151, 2153 | 2025-10-13 | 2025-10-17 | 5d | 5d | 0d |  |  | Non-SIT S&A QT Test Team | Non-SIT S&A QT Test Team | S&A Qualification | 320.33 | 6.1 | Laura Kennedy | Green | GREEN |  |  |
| 2157 | 1.6.4.3.3.2 | Qualification Wave 2 Participant Test Readiness Confirmed | milestone | 0d | 2025-10-17 | 2025-10-17 | 2156, 2144 | 2025-10-17 | 2025-10-17 | 0d | 5d | 0d |  |  | Non-SIT S&A QT Test Team | Non-SIT S&A QT Test Team | S&A Qualification | 324.71 | 6.1 | Laura Kennedy | Green | GREEN | T3-QU-0033 | QAG |
| 2158 | 1.6.4.3.3.3 | Qualification Wave 2 Execution Start | milestone | 0d | 2025-10-20 | 2025-10-20 | 2157FS+1d, 2154 | 2025-10-20 | 2025-10-20 | 0d | 5d | 0d |  |  | Participants | Participants | S&A Qualification | 327.71 | 6.1 | Laura Kennedy | Green | GREEN | T3-QU-0034 | QAG |
| 2159 | 1.6.4.3.3.4 | Qualification Wave 2 QT Execution Window |  | 95d | 2025-10-20 | 2026-02-27 | 2158SS-1d | 2025-10-20 | 2026-02-27 | 94d | 10d | 0d |  |  | Participants | Participants | S&A Qualification | 327.33 | 6.1 | Laura Kennedy | Green | GREEN |  |  |
| 2160 | 1.6.4.3.3.5 | Qualfication Wave 2 QT Execution End | milestone | 0d | 2026-02-27 | 2026-02-27 | 2159 | 2026-02-27 | 2026-02-27 | 0d | 10d | 5d |  |  | Participants | Participants | S&A Qualification | 457.71 | 6.1 | Laura Kennedy | Green | GREEN | T3-QU-0055 | QAG |
| 2161 | 1.6.4.3.4 | **Qualification Wave 2 Exit** |  | 159d | 2025-10-20 | 2026-05-28 |  | 2025-10-20 | 2026-05-28 | 153d | 5d |  |  | -0 | N/A | N/A | S&A Qualification | -154.67 | 6.1 | N/A |  |  |  |  |
| 2162 | 1.6.4.3.4.1 | Final QAD Submission window opens | milestone | 0d | 2025-10-20 | 2025-10-20 | 2158 | 2025-10-20 | 2025-10-20 | 0d | 5d | 0d |  |  | Participants | Participants | S&A Qualification | 327.71 | 6.1 | Laura Kennedy | Green | GREEN |  |  |
| 2163 | 1.6.4.3.4.2 | Qualification Wave 2 Participants submit their Final QAD |  | 100d | 2025-10-20 | 2026-03-06 | 2162FS-1d | 2025-10-20 | 2026-03-06 | 99d | 5d | 0d |  |  | Participants | Participants | S&A Qualification | 327.33 | 6.1 | Laura Kennedy | Green | GREEN |  |  |
| 2164 | 1.6.4.3.4.3 | Qualification Wave 2 Participants have submitted their final QAD | milestone | 0d | 2026-03-06 | 2026-03-06 | 2163, 2160 | 2026-03-06 | 2026-03-06 | 0d | 5d | 0d |  |  | Participants | Participants | S&A Qualification | 464.71 | 6.1 | Laura Kennedy | Green | GREEN | T3-QU-0101 | QAG |
| 2165 | 1.6.4.3.4.4 | Completion of Code Bodies review of Final QAD |  | 26d | 2026-03-09 | 2026-04-13 | 2164 | 2026-03-09 | 2026-04-13 | 27d | 5d | 0d |  |  | Code Bodies | Code Bodies | S&A Qualification | 467.33 | 6.1 | Laura Kennedy | Green | GREEN |  |  |
| 2166 | 1.6.4.3.4.5 | QAD Sign Off deadline |  | 1d | 2026-04-20 | 2026-04-20 | 2165FS+4d | 2026-04-20 | 2026-04-20 | 1d | 5d | 0d |  |  | Participants | Participants | S&A Qualification | 509.33 | 6.1 | Laura Kennedy | Green | GREEN |  |  |
| 2167 | 1.6.4.3.4.6 | Qualification Wave 2 Participants Qualification approved by BSC PAB and REC Manager | milestone | 0d | 2026-05-28 | 2026-05-28 | 2166FS+28d | 2026-05-28 | 2026-05-28 | 0d | 5d | 0d |  |  | Code Bodies | Code Bodies | S&A Qualification | 547.71 | 6.1 | Laura Kennedy | Green | GREEN | T2-QU-0200 | QAG |

Notes:
- 2167: 14/11/24 - Updated to align with the actual PAB date.

| ID | WBS | Task | Type | Duration | Start | Finish | Predecessors | Baseline start | Baseline finish | Baseline duration | Total slack | Free slack | Constraint | Baseline cost | Responsible | Involved | Text9 | Task Status | Update Version | MHHS Resource Name | Sched Status | RAG | Milestone ID | Text29 |
| --- | --- | --- | --- | --- | --- | --- | --- | --- | --- | --- | --- | --- | --- | --- | --- | --- | --- | --- | --- | --- | --- | --- | --- | --- |
| 2168 | 1.6.4.4 | **Qualification Wave 3** |  | 254d | 2025-08-11 | 2026-07-30 |  | 2025-08-11 | 2026-07-30 | 239d | 9d |  |  | -0 | N/A | N/A | S&A Qualification | -133.67 | 6.1 | N/A |  |  |  |  |
| 2169 | 1.6.4.4.1 | **Qualification Wave 3 QAD Prep** |  | 95d | 2025-08-11 | 2025-12-19 |  | 2025-08-11 | 2025-12-19 | 95d | 9d |  |  | -0 | N/A | N/A | S&A Qualification | -154.67 | 6.1 | N/A |  |  |  |  |
| 2170 | 1.6.4.4.1.1 | Initial QAD Submission window opens | milestone | 0d | 2025-08-11 | 2025-08-11 | 1894FS+151d | 2025-08-11 | 2025-08-11 | 0d | 9d | 0d |  |  | Participants | Participants | S&A Qualification | 257.71 | 6.1 | Laura Kennedy | Green | GREEN |  |  |
| 2171 | 1.6.4.4.1.2 | Qualification Wave 3 Participants Submit Initial QAD |  | 65d | 2025-08-11 | 2025-11-07 | 2170FS-1d | 2025-08-11 | 2025-11-07 | 65d | 9d | 0d |  |  | Participants | Participants | S&A Qualification | 257.33 | 6.1 | Laura Kennedy | Green | GREEN |  |  |
| 2172 | 1.6.4.4.1.3 | Qualification Wave 3 Participants have submitted their initial QAD | milestone | 0d | 2025-11-07 | 2025-11-07 | 2171 | 2025-11-07 | 2025-11-07 | 0d | 9d | 0d |  |  | Participants | Participants | S&A Qualification | 345.71 | 6.1 | Laura Kennedy | Green | GREEN | T3-QU-0102 | QAG |
| 2173 | 1.6.4.4.1.4 | Code Bodies review of Wave 3 Participants' Initial QAD |  | 30d | 2025-11-10 | 2025-12-19 | 2172 | 2025-11-10 | 2025-12-19 | 30d | 9d | 0d |  |  | Code Bodies | Code Bodies | S&A Qualification | 348.33 | 6.1 | Laura Kennedy | Green | GREEN |  |  |
| 2174 | 1.6.4.4.1.5 | Completion of Code Bodies review of Initial QAD | milestone | 0d | 2025-12-19 | 2025-12-19 | 2173 | 2025-12-19 | 2025-12-19 | 0d | 9d | 0d |  |  | Code Bodies | Code Bodies | S&A Qualification | 387.71 | 6.1 | Laura Kennedy | Green | GREEN |  |  |
| 2175 | 1.6.4.4.2 | **Qualification Wave 3 Test Prep** |  | 65d | 2025-09-15 | 2025-12-12 |  | 2025-09-15 | 2025-12-12 | 65d | 39d |  |  | -0 | N/A | N/A | S&A Qualification | -555.67 | 6.1 | N/A |  |  |  |  |
| 2176 | 1.6.4.4.2.1 | Confirmation from Qualification Wave 3 Participants that DIP Onboarding has commenced | milestone | 0d | 2025-09-15 | 2025-09-15 |  | 2025-09-15 | 2025-09-15 | 0d | 39d | 0d | start no earlier than 2025-09-15 |  | Participants | Participants | S&A Qualification | 292.33 | 6.1 | Laura Kennedy | Green | GREEN | T3-QU-0025 | QAG |
| 2177 | 1.6.4.4.2.2 | Qualification Wave 3 Participants DIP Onboarding window |  | 35d | 2025-09-15 | 2025-10-31 | 2176 | 2025-09-15 | 2025-10-31 | 40d | 39d | 0d | start no earlier than 2025-08-04 |  | Participants | Participants | S&A Qualification | 292.33 | 6.1 | Laura Kennedy | Green | GREEN |  |  |
| 2178 | 1.6.4.4.2.3 | Confirmation from Qualification Wave 3 Participants that DIP onboarding has completed | milestone | 0d | 2025-10-31 | 2025-10-31 | 2177 | 2025-10-31 | 2025-10-31 | 0d | 39d | 30d | start no earlier than 2025-09-22 |  | Participants | Participants | S&A Qualification | 338.71 | 6.1 | Laura Kennedy | Green | GREEN |  |  |
| 2179 | 1.6.4.4.2.4 | Qualification Wave 3 Participants' to provide status of PIT completion and submit QT Test Plan | milestone | 0d | 2025-10-20 | 2025-10-20 |  | 2025-10-20 | 2025-10-20 | 0d | 554d | 0d | start no earlier than 2025-10-20 |  | Participants | Participants | S&A Qualification | 327.33 | 6.1 | Laura Kennedy | Green | GREEN | T3-QU-0103 | QAG |
| 2180 | 1.6.4.4.2.5 | Review of Participants' PIT Status and QT Test Plan |  | 15d | 2025-10-20 | 2025-11-07 | 2179 | 2025-10-20 | 2025-11-07 | 15d | 554d | 0d | start no earlier than 2025-09-08 |  | Code Bodies, Non-SIT S&A QT Test Team | Code Bodies, Non-SIT S&A QT Test Team | S&A Qualification | 327.33 | 6.1 | Laura Kennedy | Green | GREEN |  |  |
| 2181 | 1.6.4.4.2.6 | Qualification Test Plans for Wave 3 Participants approved | milestone | 0d | 2025-11-07 | 2025-11-07 | 2180 | 2025-11-07 | 2025-11-07 | 0d | 554d |  | start no earlier than 2025-09-26 |  | Non-SIT S&A QT Test Team | Non-SIT S&A QT Test Team | S&A Qualification | 345.71 | 6.1 | Laura Kennedy | Green | GREEN | T3-QU-0024 | QAG |
| 2182 | 1.6.4.4.2.7 | Qualification Wave 3 Participants have submitted PIT Test Completion Report and evidence for QT Entry | milestone | 0d | 2025-11-10 | 2025-11-10 |  | 2025-11-10 | 2025-11-10 | 0d | 9d | 0d | start no earlier than 2025-11-10 |  | Participants | Participants | S&A Qualification | 348.33 | 6.1 | Laura Kennedy | Green | GREEN | T3-QU-0104 | QAG |
| 2183 | 1.6.4.4.2.8 | Review of Participants' PIT Test Completion Report |  | 25d | 2025-11-10 | 2025-12-12 | 2182 | 2025-11-10 | 2025-12-12 | 30d | 9d | 0d | start no earlier than 2025-09-29 |  | Code Bodies, Non-SIT S&A QT Test Team | Code Bodies, Non-SIT S&A QT Test Team | S&A Qualification | 348.33 | 6.1 | Laura Kennedy | Green | GREEN |  |  |
| 2184 | 1.6.4.4.2.9 | Onboarding to QTF & ADO |  | 25d | 2025-11-10 | 2025-12-12 | 2183SS | 2025-11-10 | 2025-12-12 | 30d | 9d | 0d | finish no earlier than 2025-10-31 |  |  |  | S&A Qualification | 348.33 | 6.1 | Laura Kennedy | Green | GREEN |  |  |
| 2185 | 1.6.4.4.3 | **Qualification Wave 3 QT Execution** |  | 102d | 2025-11-03 | 2026-03-24 |  | 2025-11-03 | 2026-03-24 | 100d |  |  |  | -0 | N/A | N/A | S&A Qualification | -154.67 | 6.1 | N/A |  |  |  |  |
| 2186 | 1.6.4.4.3.1 | Review Entry Criteria Evidence for each Wave 3 Participant |  | 5d | 2025-12-15 | 2025-12-19 | 2178, 2174FF, 2184 | 2025-12-15 | 2025-12-19 | 5d | 9d | 0d | start no earlier than 2025-11-03 |  | Non-SIT S&A QT Test Team | Non-SIT S&A QT Test Team | S&A Qualification | 383.33 | 6.1 | Laura Kennedy | Green | GREEN |  |  |
| 2187 | 1.6.4.4.3.2 | Qualification Wave 3 Participant Test Readiness confirmed | milestone | 0d | 2025-12-19 | 2025-12-19 | 2178, 2186 | 2025-12-19 | 2025-12-19 | 0d | 9d | 0d |  |  | Non-SIT S&A QT Test Team | Non-SIT S&A QT Test Team | S&A Qualification | 387.71 | 6.1 | Laura Kennedy | Green | GREEN | T3-QU-0038 | QAG |
| 2188 | 1.6.4.4.3.3 | Qualification Wave 3 Execution Start | milestone | 0d | 2026-01-12 | 2026-01-12 | 2187FS+16d, 2184FS+1d | 2026-01-12 | 2026-01-12 | 0d | 9d | 0d | start no earlier than 2025-11-03 |  | Participants | Participants | S&A Qualification | 411.71 | 6.1 | Laura Kennedy | Green | GREEN | T3-QU-0039 | QAG |
| 2189 | 1.6.4.4.3.4 | Qualification Wave 3 QT Execution Window |  | 90d | 2026-01-12 | 2026-05-15 | 2186, 2188FS-1d | 2026-01-12 | 2026-05-15 | 95d | 14d | 0d |  |  | Participants | Participants | S&A Qualification | 411.33 | 6.1 | Laura Kennedy | Green | GREEN |  |  |
| 2190 | 1.6.4.4.3.5 | Qualification Wave 3 Projected Execution End | milestone | 0d | 2026-05-15 | 2026-05-15 | 2189 | 2026-05-15 | 2026-05-15 | 0d | 14d | 5d |  |  | Participants | Participants | S&A Qualification | 534.71 | 6.1 | Laura Kennedy | Green | GREEN | T3-QU-0056 | QAG |
| 2191 | 1.6.4.4.4 | **Qualification Wave 3 Exit** |  | 144d | 2026-01-12 | 2026-07-30 |  | 2026-01-12 | 2026-07-30 | 144d | 9d |  |  | -0 | N/A | N/A | S&A Qualification | -154.67 | 6.1 | N/A |  |  |  |  |
| 2192 | 1.6.4.4.4.1 | Final QAD Submission window opens | milestone | 0d | 2026-01-12 | 2026-01-12 | 2188 | 2026-01-12 | 2026-01-12 | 0d | 9d | 0d |  |  | Participants | Participants | S&A Qualification | 411.71 | 6.1 | Laura Kennedy | Green | GREEN |  |  |
| 2193 | 1.6.4.4.4.2 | Qualification Wave 3 Participants submit their Final QAD |  | 95d | 2026-01-12 | 2026-05-22 | 2192FS-1d | 2026-01-12 | 2026-05-22 | 100d | 9d | 0d |  |  | Participants | Participants | S&A Qualification | 411.33 | 6.1 | Laura Kennedy | Green | GREEN |  |  |
| 2194 | 1.6.4.4.4.3 | Qualification Wave 3 Participants have submitted their Final QAD | milestone | 0d | 2026-05-22 | 2026-05-22 | 2193, 2190 | 2026-05-22 | 2026-05-22 | 0d | 9d | 0d |  |  | Participants | Participants | S&A Qualification | 541.71 | 6.1 | Laura Kennedy | Green | GREEN | T3-QU-0105 | QAG |
| 2195 | 1.6.4.4.4.4 | Completion of Code Bodies review of Final QAD |  | 20d | 2026-05-25 | 2026-06-19 | 2194 | 2026-05-25 | 2026-06-19 | 20d | 9d | 0d |  |  | Code Bodies | Code Bodies | S&A Qualification | 544.33 | 6.1 | Laura Kennedy | Green | GREEN |  |  |
| 2196 | 1.6.4.4.4.5 | QAD Sign Off deadline |  | 1d | 2026-06-26 | 2026-06-26 | 2195FS+4d | 2026-06-26 | 2026-06-26 | 1d | 9d | 0d |  |  | Participants | Participants | S&A Qualification | 576.33 | 6.1 | Laura Kennedy | Green | GREEN |  |  |
| 2197 | 1.6.4.4.4.6 | Qualification Wave 3 Participants Qualification approved by BSC PAB and REC Manager | milestone | 0d | 2026-07-30 | 2026-07-30 | 2196FS+24d | 2026-07-30 | 2026-07-30 | 0d | 9d | 0d |  |  | Code Bodies | Code Bodies | S&A Qualification | 610.71 | 6.1 | Laura Kennedy | Green | GREEN | T2-QU-0250 | QAG |

| ID | WBS | Task | Type | Duration | Start | Finish | Predecessors | Baseline start | Baseline finish | Baseline duration | Total slack | Free slack | Constraint | Baseline cost | Responsible | Involved | Text9 | Task Status | Update Version | MHHS Resource Name | Sched Status | RAG | Milestone ID | Text29 |
| --- | --- | --- | --- | --- | --- | --- | --- | --- | --- | --- | --- | --- | --- | --- | --- | --- | --- | --- | --- | --- | --- | --- | --- | --- |
| 2198 | 1.6.4.5 | **Qualification Wave 4** |  | 334d | 2025-10-20 | 2027-01-28 |  | 2025-10-20 | 2027-01-28 | 249d | 0d |  |  | -0 | N/A | N/A | S&A Qualification | -133.67 | 6.1 | N/A |  |  |  |  |
| 2199 | 1.6.4.5.1 | **Qualification Wave 4 QAD Prep** |  | 95d | 2025-10-20 | 2026-02-27 |  | 2025-10-20 | 2026-02-27 | 99d | 0d |  |  | -0 | N/A | N/A | S&A Qualification | -155.67 | 6.1 | N/A |  |  |  |  |
| 2200 | 1.6.4.5.1.1 | Initial QAD Submission window opens | milestone | 0d | 2025-10-20 | 2025-10-20 | 1895FS+161d | 2025-10-20 | 2025-10-20 | 0d | 0d |  |  |  | Participants | Participants | S&A Qualification | 327.71 | 6.1 | Laura Kennedy | Green | GREEN |  |  |
| 2201 | 1.6.4.5.1.2 | Qualification Wave 4 Participants Submit Initial QAD |  | 65d | 2025-10-20 | 2026-01-16 | 2200FS-1d | 2025-10-20 | 2026-01-16 | 70d | 0d |  |  |  | Participants | Participants | S&A Qualification | 327.33 | 6.1 | Laura Kennedy | Green | GREEN |  |  |
| 2202 | 1.6.4.5.1.3 | Qualification Wave 4 Participants have submitted their Initial QAD | milestone | 0d | 2026-01-16 | 2026-01-16 | 2201 | 2026-01-16 | 2026-01-16 | 0d | 0d |  |  |  | Participants | Participants | S&A Qualification | 415.71 | 6.1 | Laura Kennedy | Green | GREEN | T3-QU-0106 | QAG |
| 2203 | 1.6.4.5.1.4 | Code Bodies review of Wave 4 Participants' Initial QAD |  | 30d | 2026-01-19 | 2026-02-27 | 2202 | 2026-01-19 | 2026-02-27 | 29d | 0d |  |  |  | Code Bodies | Code Bodies | S&A Qualification | 418.33 | 6.1 | Laura Kennedy | Green | GREEN |  |  |
| 2204 | 1.6.4.5.1.5 | Completion of Code Bodies review of Initial QAD | milestone | 0d | 2026-02-27 | 2026-02-27 | 2203 | 2026-02-27 | 2026-02-27 | 0d | 0d |  |  |  | Code Bodies | Code Bodies | S&A Qualification | 457.71 | 6.1 | Laura Kennedy | Green | GREEN |  |  |
| 2205 | 1.6.4.5.2 | **Qualification Wave 4 Test Prep** |  | 75d | 2025-11-03 | 2026-02-13 |  | 2025-11-03 | 2026-02-13 | 67d | 16d |  |  | -0 | N/A | N/A | S&A Qualification | -555.67 | 6.1 | N/A |  |  |  |  |
| 2206 | 1.6.4.5.2.1 | Confirmation from Qualification 4 Participants that DIP Onboarding has commenced | milestone | 0d | 2025-11-03 | 2025-11-03 |  | 2025-11-03 | 2025-11-03 | 0d | 50d | 0d | start no earlier than 2025-11-03 |  | Participants | Participants | S&A Qualification | 341.33 | 6.1 | Laura Kennedy | Green | GREEN | T3-QU-0031 | QAG |
| 2207 | 1.6.4.5.2.2 | Qualification Wave 4 Participants DIP Onboarding Window |  | 35d | 2025-11-03 | 2025-12-19 | 2206 | 2025-11-03 | 2025-12-19 | 42d | 50d | 0d |  |  | Participants | Participants | S&A Qualification | 341.33 | 6.1 | Laura Kennedy | Green | GREEN |  |  |
| 2208 | 1.6.4.5.2.3 | Confirmation from Qualification Wave 4 Participants that DIP onboarding has completed | milestone | 0d | 2025-12-19 | 2025-12-19 | 2207 | 2025-12-19 | 2025-12-19 | 0d | 50d |  |  |  | Participants | Participants | S&A Qualification | 387.71 | 6.1 | Laura Kennedy | Green | GREEN |  |  |
| 2209 | 1.6.4.5.2.4 | Qualification Wave 4 Participants' to provide status of PIT completion and submit QT Test Plan | milestone | 0d | 2025-12-08 | 2025-12-08 |  | 2025-12-08 | 2025-12-08 | 0d | 16d | 0d | start no earlier than 2025-12-08 |  | Participants | Participants | S&A Qualification | 376.33 | 6.1 | Laura Kennedy | Green | GREEN | T3-QU-0107 | QAG |
| 2210 | 1.6.4.5.2.5 | Review of Participants' PIT Status and QT Test Plan |  | 25d | 2025-12-08 | 2026-01-09 | 2209 | 2025-12-08 | 2026-01-09 | 16d | 16d | 0d |  |  | Code Bodies, Non-SIT S&A QT Test Team | Code Bodies, Non-SIT S&A QT Test Team | S&A Qualification | 376.33 | 6.1 | Laura Kennedy | Green | GREEN |  |  |
| 2211 | 1.6.4.5.2.6 | Qualification Test Plans for Qualification Wave 4 Participants approved | milestone | 0d | 2026-01-09 | 2026-01-09 | 2210 | 2026-01-09 | 2026-01-09 | 0d | 16d | 0d |  |  | Non-SIT S&A QT Test Team | Non-SIT S&A QT Test Team | S&A Qualification | 408.71 | 6.1 | Laura Kennedy | Green | GREEN | T3-QU-0030 | QAG |
| 2212 | 1.6.4.5.2.7 | Qualification Wave 4 Participants have submitted PIT Test Completion Report and evidence for QT entry | milestone | 0d | 2026-01-09 | 2026-01-09 | 2211 | 2026-01-09 | 2026-01-09 | 0d | 16d | 0d |  |  | Participants | Participants | S&A Qualification | 408.71 | 6.1 | Laura Kennedy | Green | GREEN | T3-QU-0108 | QAG |
| 2213 | 1.6.4.5.2.8 | Review of Participants' PIT Test Completion Report |  | 25d | 2026-01-12 | 2026-02-13 | 2212 | 2026-01-12 | 2026-02-13 | 30d | 16d | 0d |  |  | Code Bodies, Non-SIT S&A QT Test Team | Code Bodies, Non-SIT S&A QT Test Team | S&A Qualification | 411.33 | 6.1 | Laura Kennedy | Green | GREEN |  |  |
| 2214 | 1.6.4.5.2.9 | Onboarding to QTF & ADO |  | 25d | 2026-01-12 | 2026-02-13 | 2213SS | 2026-01-12 | 2026-02-13 | 30d | 16d |  | start no earlier than 2025-11-24 |  | Code Bodies, Non-SIT S&A QT Test Team | Code Bodies, Non-SIT S&A QT Test Team | S&A Qualification | 411.33 | 6.1 | Laura Kennedy | Green | GREEN |  |  |
| 2215 | 1.6.4.5.3 | **Qualification Wave 4 QT Execution** |  | 100d | 2026-03-02 | 2026-07-17 |  | 2026-03-02 | 2026-07-17 | 101d | 0d |  |  | -0 | N/A | N/A | S&A Qualification | -155.67 | 6.1 | N/A |  |  |  |  |
| 2216 | 1.6.4.5.3.1 | Review Entry Criteria Evidence for each Wave 4 Participant |  | 5d | 2026-03-02 | 2026-03-06 | 2204FF+5d, 2208 | 2026-03-02 | 2026-03-06 | 5d | 0d |  |  |  | Non-SIT S&A QT Test Team | Non-SIT S&A QT Test Team | S&A Qualification | 460.33 | 6.1 | Laura Kennedy | Green | GREEN |  |  |
| 2217 | 1.6.4.5.3.2 | Qualification Wave 4 Participant Test Readiness Confirmed | milestone | 0d | 2026-03-06 | 2026-03-06 | 2208, 2216 | 2026-03-06 | 2026-03-06 | 0d | 0d |  |  |  | Non-SIT S&A QT Test Team | Non-SIT S&A QT Test Team | S&A Qualification | 464.71 | 6.1 | Laura Kennedy | Green | GREEN | T3-QU-0043 | QAG |
| 2218 | 1.6.4.5.3.3 | Qualification Wave 4 QT Execution Start | milestone | 0d | 2026-03-09 | 2026-03-09 | 2217FS+1d, 2214 | 2026-03-09 | 2026-03-09 | 0d | 0d |  | start no earlier than 2026-01-07 |  | Participants | Participants | S&A Qualification | 467.71 | 6.1 | Laura Kennedy | Green | GREEN | T3-QU-0044 | QAG |
| 2219 | 1.6.4.5.3.4 | Qualification Wave 4 QT Execution Window |  | 95d | 2026-03-09 | 2026-07-17 | 2218FS-1d, 2216 | 2026-03-09 | 2026-07-17 | 96d | 5d | 0d |  |  | Participants | Participants | S&A Qualification | 467.33 | 6.1 | Laura Kennedy | Green | GREEN |  |  |
| 2220 | 1.6.4.5.3.5 | Qualification Wave 4 Projected Execution End | milestone | 0d | 2026-07-17 | 2026-07-17 | 2219 | 2026-07-17 | 2026-07-17 | 0d | 5d |  |  |  | Participants | Participants | S&A Qualification | 597.71 | 6.1 | Laura Kennedy | Green | GREEN | T3-QU-0057 | QAG |
| 2221 | 1.6.4.5.4 | **Qualification Wave 4 Exit** |  | 144d | 2026-03-09 | 2026-09-24 |  | 2026-03-09 | 2026-09-24 | 150d | 0d |  |  | -0 | N/A | N/A | S&A Qualification | -155.67 | 6.1 | N/A |  |  |  |  |
| 2222 | 1.6.4.5.4.1 | Final QAD Submission window opens | milestone | 0d | 2026-03-09 | 2026-03-09 | 2218 | 2026-03-09 | 2026-03-09 | 0d | 0d |  |  |  | Participants | Participants | S&A Qualification | 467.71 | 6.1 | Laura Kennedy | Green | GREEN |  |  |
| 2223 | 1.6.4.5.4.2 | Qualification Wave 4 Participants submit their Final QAD |  | 100d | 2026-03-09 | 2026-07-24 | 2222FS-1d | 2026-03-09 | 2026-07-24 | 101d | 0d |  |  |  | Participants | Participants | S&A Qualification | 467.33 | 6.1 | Laura Kennedy | Green | GREEN |  |  |
| 2224 | 1.6.4.5.4.3 | Qualification Wave 4 Participants have submitted their Final QAD | milestone | 0d | 2026-07-24 | 2026-07-24 | 2223, 2220 | 2026-07-24 | 2026-07-24 | 0d | 0d |  |  |  | Participants | Participants | S&A Qualification | 604.71 | 6.1 | Laura Kennedy | Green | GREEN | T3-QU-0109 | QAG |
| 2225 | 1.6.4.5.4.4 | Completion of Code Bodies review of Final QAD |  | 20d | 2026-07-27 | 2026-08-21 | 2224 | 2026-07-27 | 2026-08-21 | 25d | 0d |  |  |  | Code Bodies | Code Bodies | S&A Qualification | 607.33 | 6.1 | Laura Kennedy | Green | GREEN |  |  |
| 2226 | 1.6.4.5.4.5 | QAD Sign Off deadline |  | 1d | 2026-08-28 | 2026-08-28 | 2225FS+4d | 2026-08-28 | 2026-08-28 | 1d | 0d |  |  |  | Participants | Participants | S&A Qualification | 639.33 | 6.1 | Laura Kennedy | Green | GREEN |  |  |
| 2227 | 1.6.4.5.4.6 | Qualification Wave 4 Participants Qualification approved by BSC PAB and REC Manager | milestone | 0d | 2026-09-24 | 2026-09-24 | 2226FS+19d | 2026-09-24 | 2026-09-24 | 0d | 0d |  |  |  | Code Bodies | Code Bodies | S&A Qualification | 666.71 | 6.1 | Laura Kennedy | Green | GREEN | T2-QU-0300 | QAG |

| ID | WBS | Task | Type | Duration | Start | Finish | Predecessors | Complete | Remaining | Baseline start | Baseline finish | Baseline duration | Baseline 1 start | Baseline 1 finish | Total slack | Free slack | Constraint | Baseline cost | Text9 | Task Status | Sched Status | Responsible | Involved | Update Version | MHHS Resource Name | MHHS Programme Phase | RAG | Milestone ID | Text29 | Tier | Artefact ID |
| --- | --- | --- | --- | --- | --- | --- | --- | --- | --- | --- | --- | --- | --- | --- | --- | --- | --- | --- | --- | --- | --- | --- | --- | --- | --- | --- | --- | --- | --- | --- | --- |
| 2228 | 1.6.4.5.5 | **Qualification Tier 1 Milestone** |  | 66d | 2026-10-28 | 2027-01-28 |  |  |  | 2026-10-28 | 2027-01-28 | 0d |  |  | 235d |  |  |  | S&A Qualification | -686.67 | Overdue Start |  |  |  |  |  |  |  |  |  |  |
| 2229 | 1.6.4.5.5.1 | All suppliers must be able to access MPANs under the new TOM (M14) | milestone | 0d | 2026-10-28 | 2026-10-28 | 2227FS+24d |  |  | 2026-10-28 | 2026-10-28 | 0d | 2026-03-16 | 2026-03-16 | 235d | 0d | start no earlier than 2026-03-12 |  | S&A Qualification | 700.71 | Green | CPT | CPT | 6.1 | CPT | Migration | GREEN | T1-MI-5000 | PSG | T1 |  |
| 2230 | 1.6.4.5.5.2 | All suppliers must be able to access MPANs under the new TOM (M14*) - Late Exit | milestone | 0d | 2027-01-28 | 2027-01-28 | 2229FS+66d |  |  | 2027-01-28 | 2027-01-28 | 0d | 2026-06-16 | 2026-06-16 | 235d |  |  |  | S&A Qualification | 792.71 | Green | CPT | CPT | 6.1 | CPT | Migration | GREEN | T1-MI-5500 | PSG | T1 |  |
| 2231 | 1.7 | **REGULATORY** |  | 822d | 2022-10-31 A | 2025-12-23 |  | 99% | 11.37d | 2022-10-31 | 2025-12-24 | 680d | 2022-10-31 | 2025-03-07 | 522d |  |  | -0 | Regulatory |  |  | N/A | N/A |  | N/A | Regulatory |  |  |  |  |  |
| 2232 | 1.7.1 | **Baseline MHHS Code Changes** |  | 475d | 2022-10-31 A | 2024-08-23 A |  | 100% |  | 2022-10-31 | 2024-08-23 | 475d | 2022-10-31 | 2024-08-23 |  |  |  | -0 | Regulatory |  |  | N/A | N/A | 5.0 | N/A | Regulatory |  |  |  |  |  |
| 2233 | 1.7.1.1 | **Preparation and planning** |  | 35d | 2022-10-31 A | 2022-12-16 A |  | 100% |  | 2022-10-31 | 2022-12-16 | 35d | 2022-10-31 | 2022-12-16 |  |  |  |  | Regulatory |  |  | N/A | N/A | 5.0 | N/A | Regulatory |  |  |  |  |  |
| 2234 | 1.7.1.1.1 | Impact assessment of Programme design on codes to determine required changes |  | 20d | 2022-10-31 A | 2022-11-25 A | 47 | 100% |  | 2022-10-31 | 2022-11-25 | 20d | 2022-10-31 | 2022-11-25 |  |  |  |  | Regulatory |  | Complete | Code Bodies,SRO Code Drafters | Code Drafting PM | 5.0 | Andrew Margan | Regulatory | COMPLETE |  |  |  |  |
| 2235 | 1.7.1.1.2 | Become 'code draft ready' |  | 35d | 2022-10-31 A | 2022-12-16 A |  | 100% |  | 2022-10-31 | 2022-12-16 | 35d | 2022-10-31 | 2022-12-16 |  |  |  |  | Regulatory |  | Complete | Code Bodies,SRO Code Drafters | Code Drafting PM | 5.0 | Andrew Margan | Regulatory | COMPLETE |  |  |  |  |
| 2236 | 1.7.1.1.3 | Soft start drafting where possible |  | 35d | 2022-10-31 A | 2022-12-16 A |  | 100% |  | 2022-10-31 | 2022-12-16 | 35d | 2022-10-31 | 2022-12-16 |  |  |  |  | Regulatory |  | Complete | Code Bodies,SRO Code Drafters | Code Drafting PM | 5.0 | Andrew Margan | Regulatory | COMPLETE |  |  |  |  |
| 2237 | 1.7.1.2 | **Code drafting** |  | 443d | 2022-12-12 A | 2024-08-21 A |  | 100% |  | 2022-12-12 | 2024-08-21 | 445d | 2022-12-12 | 2024-08-23 |  |  |  | -0 | Regulatory | M6 |  | N/A | N/A | 5.0 | N/A | Regulatory |  |  |  |  |  |
| 2238 | 1.7.1.2.1 | **Data Services (BSC driven)** |  | 118d | 2022-12-12 A | 2023-05-24 A |  | 100% |  | 2022-12-12 | 2023-05-24 | 118d | 2022-12-12 | 2023-05-24 |  |  |  |  | Regulatory | M6 |  | N/A | N/A | 5.0 | N/A | Regulatory |  |  |  |  |  |
| 2239 | 1.7.1.2.1.1 | Pre Code Drafting activities |  | 5d | 2022-12-12 A | 2022-12-16 A |  | 100% |  | 2022-12-12 | 2022-12-16 | 5d | 2022-12-12 | 2022-12-16 |  |  | start no earlier than 2022-12-12 |  | Regulatory |  | Complete | Code Drafting PM |  | 5.0 | Andrew Margan | Regulatory | COMPLETE |  |  |  |  |
| 2240 | 1.7.1.2.1.2 | Code and subsidiary document drafting takes place offline |  | 19d | 2023-01-03 A | 2023-01-27 A | 2239FS+11d | 100% |  | 2023-01-03 | 2023-01-27 | 19d | 2023-01-03 | 2023-01-27 |  |  |  |  | Regulatory |  | Complete | Code Bodies,SRO Design | Code Drafting PM | 5.0 | Andrew Margan | Regulatory | COMPLETE |  |  |  |  |
| 2241 | 1.7.1.2.1.3 | Internal review and cross-checking of drafting across code drafters |  | 11d | 2023-01-30 A | 2023-02-13 A | 2240 | 100% |  | 2023-01-30 | 2023-02-13 | 11d | 2023-01-30 | 2023-02-13 |  |  |  |  | Regulatory |  | Complete | Code Bodies,SRO Design | Code Drafting PM | 5.0 | Andrew Margan | Regulatory | COMPLETE |  |  |  |  |
| 2242 | 1.7.1.2.1.4 | External industry review via consultation |  | 20d | 2023-02-14 A | 2023-03-13 A | 2241 | 100% |  | 2023-02-14 | 2023-03-13 | 20d | 2023-02-14 | 2023-03-13 |  |  |  |  | Regulatory |  | Complete | PP | Code Drafting PM | 5.0 | Andrew Margan | Regulatory | COMPLETE |  |  |  |  |
| 2243 | 1.7.1.2.1.5 | Triage and action comments |  | 19d | 2023-03-10 A | 2023-04-05 A | 2242FS-2d | 100% |  | 2023-03-10 | 2023-04-05 | 19d | 2023-03-10 | 2023-04-05 |  |  |  |  | Regulatory |  | Complete | Code Bodies,SRO Design | Code Drafting PM | 5.0 | Andrew Margan | Regulatory | COMPLETE |  |  |  |  |
| 2244 | 1.7.1.2.1.6 | CDWG review |  | 30d | 2023-04-06 A | 2023-05-17 A | 2243 | 100% |  | 2023-04-06 | 2023-05-17 | 30d | 2023-04-06 | 2023-05-17 |  |  |  |  | Regulatory |  | Complete | PP | Code Drafting PM | 5.0 | Andrew Margan | Regulatory | COMPLETE |  |  |  |  |
| 2245 | 1.7.1.2.1.7 | CCAG review |  | 5d | 2023-05-18 A | 2023-05-24 A | 2244 | 100% |  | 2023-05-18 | 2023-05-24 | 5d | 2023-05-18 | 2023-05-24 |  |  |  |  | Regulatory |  | Complete | PP |  | 5.0 | Andrew Margan | Regulatory | COMPLETE |  |  |  |  |
| 2246 | 1.7.1.2.1.8 | Code drafting for Data Services topic area approved | milestone | 0d | 2023-05-24 A | 2023-05-24 A | 2245 | 100% |  | 2023-05-24 | 2023-05-24 | 0d | 2023-05-24 | 2023-05-24 |  |  |  |  | Regulatory |  | Complete | PP | Code Drafting PM | 5.0 | Andrew Margan | Regulatory | COMPLETE | T2-RE-0100 | CCAG | T2 | MHHS-ART060 |
| 2247 | 1.7.1.2.2 | **Metering (REC driven)** |  | 118d | 2022-12-12 A | 2023-05-24 A |  | 100% |  | 2022-12-12 | 2023-05-24 | 118d | 2022-12-12 | 2023-05-24 |  |  |  |  | Regulatory | M6 |  | N/A | N/A | 5.0 | N/A | Regulatory |  |  |  |  |  |
| 2248 | 1.7.1.2.2.1 | Pre Code Drafting activities |  | 5d | 2022-12-12 A | 2022-12-16 A | 2239SS | 100% |  | 2022-12-12 | 2022-12-16 | 5d | 2022-12-12 | 2022-12-16 |  |  |  |  | Regulatory |  | Complete | Code Drafting PM |  | 5.0 | Andrew Margan | Regulatory | COMPLETE |  |  |  |  |
| 2249 | 1.7.1.2.2.2 | Code and subsidiary document drafting takes place offline |  | 19d | 2023-01-03 A | 2023-01-27 A | 2248FS+11d | 100% |  | 2023-01-03 | 2023-01-27 | 19d | 2023-01-03 | 2023-01-27 |  |  |  |  | Regulatory |  | Complete | Code Bodies,SRO Design | Code Drafting PM | 5.0 | Andrew Margan | Regulatory | COMPLETE |  |  |  |  |
| 2250 | 1.7.1.2.2.3 | Internal review and cross-checking of drafting across code drafters |  | 11d | 2023-01-30 A | 2023-02-13 A | 2249 | 100% |  | 2023-01-30 | 2023-02-13 | 11d | 2023-01-30 | 2023-02-13 |  |  |  |  | Regulatory |  | Complete | Code Bodies,SRO Design | Code Drafting PM | 5.0 | Andrew Margan | Regulatory | COMPLETE |  |  |  |  |
| 2251 | 1.7.1.2.2.4 | External industry review via consultation |  | 20d | 2023-02-14 A | 2023-03-13 A | 2250 | 100% |  | 2023-02-14 | 2023-03-13 | 20d | 2023-02-14 | 2023-03-13 |  |  |  |  | Regulatory |  | Complete | PP | Code Drafting PM | 5.0 | Andrew Margan | Regulatory | COMPLETE |  |  |  |  |
| 2252 | 1.7.1.2.2.5 | Triage and action comments |  | 19d | 2023-03-10 A | 2023-04-05 A | 2251FS-2d | 100% |  | 2023-03-10 | 2023-04-05 | 19d | 2023-03-10 | 2023-04-05 |  |  |  |  | Regulatory |  | Complete | Code Bodies,SRO Design | Code Drafting PM | 5.0 | Andrew Margan | Regulatory | COMPLETE |  |  |  |  |
| 2253 | 1.7.1.2.2.6 | CDWG review |  | 30d | 2023-04-06 A | 2023-05-17 A | 2252 | 100% |  | 2023-04-06 | 2023-05-17 | 30d | 2023-04-06 | 2023-05-17 |  |  |  |  | Regulatory |  | Complete | PP | Code Drafting PM | 5.0 | Andrew Margan | Regulatory | COMPLETE |  |  |  |  |
| 2254 | 1.7.1.2.2.7 | CCAG review |  | 5d | 2023-05-18 A | 2023-05-24 A | 2253 | 100% |  | 2023-05-18 | 2023-05-24 | 5d | 2023-05-18 | 2023-05-24 |  |  |  |  | Regulatory |  | Complete | PP |  | 5.0 | Andrew Margan | Regulatory | COMPLETE |  |  |  |  |
| 2255 | 1.7.1.2.2.8 | Code drafting for Metering topic area approved | milestone | 0d | 2023-05-24 A | 2023-05-24 A | 2254 | 100% |  | 2023-05-24 | 2023-05-24 | 0d | 2023-05-24 | 2023-05-24 |  |  |  |  | Regulatory |  | Complete | PP | Code Drafting PM | 5.0 | Andrew Margan | Regulatory | COMPLETE | T2-RE-0150 | CCAG | T2 | MHHS-ART060 |

Notes:
- 2229: Future RAG: All suppliers must be able to accept MPANs under the new TOM (one way gate)
- 2230: Future RAG: All suppliers must be able to accept MPANs under the new TOM (one way gate)

| ID | WBS | Task | Type | Duration | Start | Finish | Predecessors | Complete | Baseline start | Baseline finish | Baseline duration | Baseline 1 start | Baseline 1 finish | Constraint | Responsible | Involved | Text9 | Task Status | Update Version | MHHS Resource Name | MHHS Programme Phase | Sched Status | RAG | Artefact ID | Milestone ID | Text29 | Tier |
| --- | --- | --- | --- | --- | --- | --- | --- | --- | --- | --- | --- | --- | --- | --- | --- | --- | --- | --- | --- | --- | --- | --- | --- | --- | --- | --- | --- |
| 2256 | 1.7.1.2.3 | **BSC Central Services (BSC driven)** |  | 156d | 2023-02-22 A | 2023-09-27 A |  | 100% | 2023-02-22 | 2023-09-27 | 156d | 2023-02-22 | 2023-09-14 |  | N/A | N/A | Regulatory | M6 | 5.0 | N/A | Regulatory |  |  |  |  |  |  |
| 2257 | 1.7.1.2.3.1 | Pre Code Drafting activities |  | 5d | 2023-02-22 A | 2023-02-28 A | 2258SS-5d | 100% | 2023-02-22 | 2023-02-28 | 5d | 2023-02-22 | 2023-02-28 |  | Code Drafting PM |  | Regulatory |  | 5.0 | Andrew Margan | Regulatory | Complete | COMPLETE |  |  |  |  |
| 2258 | 1.7.1.2.3.2 | Code Drafting (offline) |  | 80d | 2023-03-01 A | 2023-06-20 A | 2242SS | 100% | 2023-03-01 | 2023-06-20 | 80d | 2023-03-01 | 2023-06-20 | must start on 2023-03-01 | Code Bodies,SRO Design | Code Drafting PM | Regulatory |  | 5.0 | Andrew Margan | Regulatory | Complete | COMPLETE |  |  |  |  |
| 2259 | 1.7.1.2.3.3 | Internal review and cross-checking of drafting across code drafters |  | 70d | 2023-03-15 A | 2023-06-20 A | 2258SS+10d | 100% | 2023-03-15 | 2023-06-20 | 70d | 2023-03-15 | 2023-06-20 |  | Code Bodies,SRO Design | Code Drafting PM | Regulatory |  | 5.0 | Andrew Margan | Regulatory | Complete | COMPLETE |  |  |  |  |
| 2260 | 1.7.1.2.3.4 | External industry review via consultation |  | 15d | 2023-06-21 A | 2023-07-11 A | 2259 | 100% | 2023-06-21 | 2023-07-11 | 15d | 2023-06-21 | 2023-07-11 |  | PP | Code Drafting PM | Regulatory |  | 5.0 | Andrew Margan | Regulatory | Complete | COMPLETE |  |  |  |  |
| 2261 | 1.7.1.2.3.5 | Triage and action comments |  | 19d | 2023-07-10 A | 2023-08-03 A | 2260FS-2d | 100% | 2023-07-10 | 2023-08-03 | 19d | 2023-07-10 | 2023-08-03 |  | Code Bodies,SRO Design | Code Drafting PM | Regulatory |  | 5.0 | Andrew Margan | Regulatory | Complete | COMPLETE |  |  |  |  |
| 2262 | 1.7.1.2.3.6 | CDWG review |  | 28d | 2023-08-04 A | 2023-09-12 A | 2261 | 100% | 2023-08-04 | 2023-09-12 | 28d | 2023-08-04 | 2023-09-07 |  | PP | Code Drafting PM | Regulatory |  | 5.0 | Andrew Margan | Regulatory | Complete | COMPLETE |  |  |  |  |
| 2263 | 1.7.1.2.3.7 | CCAG review |  | 11d | 2023-09-13 A | 2023-09-27 A | 2262 | 100% | 2023-09-13 | 2023-09-27 | 11d | 2023-09-08 | 2023-09-14 |  | PP |  | Regulatory |  | 5.0 | Andrew Margan | Regulatory | Complete | COMPLETE |  |  |  |  |
| 2264 | 1.7.1.2.3.8 | Code drafting for BSC Central Services topic area approved | milestone | 0d | 2023-09-27 A | 2023-09-27 A | 2263 | 100% | 2023-09-27 | 2023-09-27 | 0d | 2023-09-14 | 2023-09-14 |  | PP | Code Drafting PM | Regulatory |  | 5.0 | Andrew Margan | Regulatory | Complete | COMPLETE | MHHS-ART060 | T2-RE-0200 | CCAG | T2 |
| 2265 | 1.7.1.2.4 | **Registration (BSC & REC driven)** |  | 131d | 2023-02-22 A | 2023-08-23 A |  | 100% | 2023-02-22 | 2023-08-23 | 131d | 2023-02-22 | 2023-08-23 |  | N/A | N/A | Regulatory | M6 | 5.0 | N/A | Regulatory |  |  |  |  |  |  |
| 2266 | 1.7.1.2.4.1 | Pre Code Drafting activities |  | 5d | 2023-02-22 A | 2023-02-28 A | 2267SS-5d | 100% | 2023-02-22 | 2023-02-28 | 5d | 2023-02-22 | 2023-02-28 |  | Code Drafting PM |  | Regulatory |  | 5.0 | Andrew Margan | Regulatory | Complete | COMPLETE |  |  |  |  |
| 2267 | 1.7.1.2.4.2 | Code Drafting (offline) |  | 65d | 2023-03-01 A | 2023-05-30 A | 2241, 2250 | 100% | 2023-03-01 | 2023-05-30 | 65d | 2023-03-01 | 2023-05-30 | must start on 2023-03-01 | Code Bodies,SRO Design | Code Drafting PM | Regulatory |  | 5.0 | Andrew Margan | Regulatory | Complete | COMPLETE |  |  |  |  |
| 2268 | 1.7.1.2.4.3 | Internal review and cross-checking of drafting across code drafters |  | 55d | 2023-03-15 A | 2023-05-30 A | 2267SS+10d | 100% | 2023-03-15 | 2023-05-30 | 55d | 2023-03-15 | 2023-05-30 |  | Code Bodies,SRO Design | Code Drafting PM | Regulatory |  | 5.0 | Andrew Margan | Regulatory | Complete | COMPLETE |  |  |  |  |
| 2269 | 1.7.1.2.4.4 | External industry review via consultation |  | 15d | 2023-05-31 A | 2023-06-20 A | 2268 | 100% | 2023-05-31 | 2023-06-20 | 15d | 2023-05-31 | 2023-06-20 |  | PP | Code Drafting PM | Regulatory |  | 5.0 | Andrew Margan | Regulatory | Complete | COMPLETE |  |  |  |  |
| 2270 | 1.7.1.2.4.5 | Triage and action comments |  | 19d | 2023-06-19 A | 2023-07-13 A | 2269FS-2d | 100% | 2023-06-19 | 2023-07-13 | 19d | 2023-06-19 | 2023-07-13 |  | Code Bodies,SRO Design | Code Drafting PM | Regulatory |  | 5.0 | Andrew Margan | Regulatory | Complete | COMPLETE |  |  |  |  |
| 2271 | 1.7.1.2.4.6 | CDWG review |  | 18d | 2023-07-14 A | 2023-08-08 A | 2270 | 100% | 2023-07-14 | 2023-08-08 | 18d | 2023-07-14 | 2023-08-16 |  | PP | Code Drafting PM | Regulatory |  | 5.0 | Andrew Margan | Regulatory | Complete | COMPLETE |  |  |  |  |
| 2272 | 1.7.1.2.4.7 | CCAG review |  | 11d | 2023-08-09 A | 2023-08-23 A | 2271 | 100% | 2023-08-09 | 2023-08-23 | 11d | 2023-08-17 | 2023-08-23 |  | PP |  | Regulatory |  | 5.0 | Andrew Margan | Regulatory | Complete | COMPLETE |  |  |  |  |
| 2273 | 1.7.1.2.4.8 | Code drafting for Registration topic area approved | milestone | 0d | 2023-08-23 A | 2023-08-23 A | 2272 | 100% | 2023-08-23 | 2023-08-23 | 0d | 2023-08-23 | 2023-08-23 |  | PP | Code Drafting PM | Regulatory |  | 5.0 | Andrew Margan | Regulatory | Complete | COMPLETE | MHHS-ART060 | T2-RE-0250 | CCAG | T2 |
| 2274 | 1.7.1.2.5 | **Governance and Qualification (BSC & REC driven)** |  | 130d | 2023-05-25 A | 2023-11-22 A |  | 100% | 2023-05-25 | 2023-11-22 | 130d | 2023-05-25 | 2023-11-13 |  | N/A | N/A | Regulatory | M6 | 5.0 | N/A | Regulatory |  |  |  |  |  |  |
| 2275 | 1.7.1.2.5.1 | Pre Code Drafting activities |  | 5d | 2023-05-25 A | 2023-05-31 A | 2276SS-5d | 100% | 2023-05-25 | 2023-05-31 | 5d | 2023-05-25 | 2023-05-31 |  | Code Drafting PM |  | Regulatory |  | 5.0 | Andrew Margan | Regulatory | Complete | COMPLETE |  |  |  |  |
| 2276 | 1.7.1.2.5.2 | Code Drafting (offline) |  | 55d | 2023-06-01 A | 2023-08-16 A | 2269SS+1d | 100% | 2023-06-01 | 2023-08-16 | 55d | 2023-06-01 | 2023-08-16 |  | Code Bodies,SRO Design | Code Drafting PM | Regulatory |  | 5.0 | Andrew Margan | Regulatory | Complete | COMPLETE |  |  |  |  |
| 2277 | 1.7.1.2.5.3 | Internal review and cross-checking of drafting across code drafters |  | 45d | 2023-06-15 A | 2023-08-16 A | 2276SS+10d | 100% | 2023-06-15 | 2023-08-16 | 45d | 2023-06-15 | 2023-08-16 |  | Code Bodies,SRO Design | Code Drafting PM | Regulatory |  | 5.0 | Andrew Margan | Regulatory | Complete | COMPLETE |  |  |  |  |
| 2278 | 1.7.1.2.5.4 | External industry review via consultation |  | 15d | 2023-08-18 A | 2023-09-07 A | 2277FS+1d | 100% | 2023-08-18 | 2023-09-07 | 15d | 2023-08-18 | 2023-09-07 |  | PP | Code Drafting PM | Regulatory |  | 5.0 | Andrew Margan | Regulatory | Complete | COMPLETE |  |  |  |  |
| 2279 | 1.7.1.2.5.5 | Triage and action comments |  | 19d | 2023-09-06 A | 2023-10-02 A | 2278FS-2d | 100% | 2023-09-06 | 2023-10-02 | 19d | 2023-09-06 | 2023-10-02 |  | Code Bodies,SRO Design | Code Drafting PM | Regulatory |  | 5.0 | Andrew Margan | Regulatory | Complete | COMPLETE |  |  |  |  |
| 2280 | 1.7.1.2.5.6 | CDWG review |  | 31d | 2023-10-03 A | 2023-11-14 A | 2279 | 100% | 2023-10-03 | 2023-11-14 | 31d | 2023-10-03 | 2023-11-06 |  | PP | Code Drafting PM | Regulatory |  | 5.0 | Andrew Margan | Regulatory | Complete | COMPLETE |  |  |  |  |
| 2281 | 1.7.1.2.5.7 | CCAG review |  | 6d | 2023-11-15 A | 2023-11-22 A | 2280 | 100% | 2023-11-15 | 2023-11-22 | 6d | 2023-11-07 | 2023-11-13 |  | PP |  | Regulatory |  | 5.0 | Andrew Margan | Regulatory | Complete | COMPLETE |  |  |  |  |
| 2282 | 1.7.1.2.5.8 | Code drafting for Governance and Qualification topic areas approved | milestone | 0d | 2023-11-22 A | 2023-11-22 A | 2281 | 100% | 2023-11-22 | 2023-11-22 | 0d | 2023-11-13 | 2023-11-13 |  | PP | Code Drafting PM | Regulatory |  | 5.12 | Andrew Margan | Regulatory | Complete | COMPLETE | MHHS-ART060 | T3-RE-0300 | CCAG | T2 |

| ID | WBS | Task | Type | Duration | Start | Finish | Predecessors | Complete | Baseline start | Baseline finish | Baseline duration | Baseline 1 start | Baseline 1 finish | Constraint | Baseline cost | Responsible | Involved | Text9 | Task Status | Update Version | MHHS Resource Name | MHHS Programme Phase | Sched Status | RAG | Artefact ID | Milestone ID | Text29 | Tier |
| --- | --- | --- | --- | --- | --- | --- | --- | --- | --- | --- | --- | --- | --- | --- | --- | --- | --- | --- | --- | --- | --- | --- | --- | --- | --- | --- | --- | --- |
| 2283 | 1.7.1.2.6 | **Interfaces / Data Specification (REC driven)** |  | 174d | 2023-05-25 A | 2024-01-23 A |  | 100% | 2023-05-25 | 2024-01-23 | 175d | 2023-05-25 | 2023-11-13 |  |  | N/A | N/A | Regulatory | M6 | 5.2 | N/A | Regulatory |  |  |  |  |  |  |
| 2284 | 1.7.1.2.6.1 | Pre Code Drafting activities |  | 5d | 2023-05-25 A | 2023-05-31 A | 2285SS-5d | 100% | 2023-05-25 | 2023-05-31 | 5d | 2023-05-25 | 2023-05-31 |  |  | Code Drafting PM |  | Regulatory |  | 5.0 | Andrew Margan | Regulatory | Complete | COMPLETE |  |  |  |  |
| 2285 | 1.7.1.2.6.2 | Code Drafting (offline) |  | 94d | 2023-06-01 A | 2023-10-10 A | 2269SS+1d | 100% | 2023-06-01 | 2023-10-10 | 94d | 2023-06-01 | 2023-08-16 |  |  | Code Bodies,SRO Design | Code Drafting PM | Regulatory |  | 5.2 | Andrew Margan | Regulatory | Complete | COMPLETE |  |  |  |  |
| 2286 | 1.7.1.2.6.3 | Internal review and cross-checking of drafting across code drafters |  | 84d | 2023-06-15 A | 2023-10-10 A | 2285SS+10d | 100% | 2023-06-15 | 2023-10-10 | 84d | 2023-06-15 | 2023-08-16 |  |  | Code Bodies,SRO Design | Code Drafting PM | Regulatory |  | 5.2 | Andrew Margan | Regulatory | Complete | COMPLETE |  |  |  |  |
| 2287 | 1.7.1.2.6.4 | External industry review via consultation |  | 15d | 2023-10-11 A | 2023-10-31 A | 2286 | 100% | 2023-10-11 | 2023-10-31 | 15d | 2023-08-18 | 2023-09-07 |  |  | PP | Code Drafting PM | Regulatory |  | 5.2 | Andrew Margan | Regulatory | Complete | COMPLETE |  |  |  |  |
| 2288 | 1.7.1.2.6.5 | Triage and action comments |  | 20d | 2023-10-30 A | 2023-11-24 A | 2287FS-2d | 100% | 2023-10-30 | 2023-11-24 | 20d | 2023-09-06 | 2023-10-02 |  |  | Code Bodies,SRO Design | Code Drafting PM | Regulatory |  | 5.2 | Andrew Margan | Regulatory | Complete | COMPLETE |  |  |  |  |
| 2289 | 1.7.1.2.6.6 | CDWG review |  | 37d | 2023-11-27 A | 2024-01-16 A | 2288 | 100% | 2023-11-27 | 2024-01-16 | 32d | 2023-10-03 | 2023-11-06 |  |  | PP | Code Drafting PM | Regulatory |  | 5.2 | Andrew Margan | Regulatory | Complete | COMPLETE |  |  |  |  |
| 2290 | 1.7.1.2.6.7 | CCAG review |  | 5d | 2024-01-17 A | 2024-01-23 A | 2289 | 100% | 2024-01-17 | 2024-01-23 | 11d | 2023-11-07 | 2023-11-13 |  |  | PP | Code Drafting PM | Regulatory |  | 5.2 | Andrew Margan | Regulatory | Complete | COMPLETE |  |  |  |  |
| 2291 | 1.7.1.2.6.8 | Code drafting for Interfaces / Data Specification topic areas approved | milestone | 0d | 2024-01-23 A | 2024-01-23 A | 2290 | 100% | 2024-01-23 | 2024-01-23 | 0d | 2023-11-13 | 2023-11-13 |  |  | PP | Code Drafting PM | Regulatory |  | 5.16 | Andrew Margan | Regulatory | Complete | COMPLETE | MHHS-ART060 | T3-RE-0350 | CCAG | T2 |
| 2292 | 1.7.1.2.7 | **Migration (BSC & REC driven)** |  | 130d | 2023-05-25 A | 2023-11-22 A |  | 100% | 2023-05-25 | 2023-11-22 | 130d | 2023-05-25 | 2023-11-13 |  |  | N/A | N/A | Regulatory | M6 | 5.0 | N/A | Regulatory |  |  |  |  |  |  |
| 2293 | 1.7.1.2.7.1 | Pre Code Drafting activities |  | 5d | 2023-05-25 A | 2023-05-31 A | 2294SS-5d | 100% | 2023-05-25 | 2023-05-31 | 5d | 2023-05-25 | 2023-05-31 |  |  | Code Drafting PM |  | Regulatory |  | 5.0 | Andrew Margan | Regulatory | Complete | COMPLETE |  |  |  |  |
| 2294 | 1.7.1.2.7.2 | Code Drafting (offline) |  | 55d | 2023-06-01 A | 2023-08-16 A | 2269SS+1d | 100% | 2023-06-01 | 2023-08-16 | 55d | 2023-06-01 | 2023-08-16 |  |  | Code Bodies,SRO Design | Code Drafting PM | Regulatory |  | 5.0 | Andrew Margan | Regulatory | Complete | COMPLETE |  |  |  |  |
| 2295 | 1.7.1.2.7.3 | Internal review and cross-checking of drafting across code drafters |  | 45d | 2023-06-15 A | 2023-08-16 A | 2294SS+10d | 100% | 2023-06-15 | 2023-08-16 | 45d | 2023-06-15 | 2023-08-16 |  |  | Code Bodies,SRO Design | Code Drafting PM | Regulatory |  | 5.0 | Andrew Margan | Regulatory | Complete | COMPLETE |  |  |  |  |
| 2296 | 1.7.1.2.7.4 | External industry review via consultation |  | 15d | 2023-08-18 A | 2023-09-07 A | 2295FS+1d | 100% | 2023-08-18 | 2023-09-07 | 15d | 2023-08-18 | 2023-09-07 |  |  | PP | Code Drafting PM | Regulatory |  | 5.0 | Andrew Margan | Regulatory | Complete | COMPLETE |  |  |  |  |
| 2297 | 1.7.1.2.7.5 | Triage and action comments |  | 19d | 2023-09-06 A | 2023-10-02 A | 2296FS-2d | 100% | 2023-09-06 | 2023-10-02 | 19d | 2023-09-06 | 2023-10-02 |  |  | Code Bodies,SRO Design | Code Drafting PM | Regulatory |  | 5.0 | Andrew Margan | Regulatory | Complete | COMPLETE |  |  |  |  |
| 2298 | 1.7.1.2.7.6 | CDWG review |  | 31d | 2023-10-03 A | 2023-11-14 A | 2297 | 100% | 2023-10-03 | 2023-11-14 | 31d | 2023-10-03 | 2023-11-06 |  |  | PP | Code Drafting PM | Regulatory |  | 5.0 | Andrew Margan | Regulatory | Complete | COMPLETE |  |  |  |  |
| 2299 | 1.7.1.2.7.7 | CCAG review |  | 6d | 2023-11-15 A | 2023-11-22 A | 2298 | 100% | 2023-11-15 | 2023-11-22 | 6d | 2023-11-07 | 2023-11-13 |  |  | PP | Code Drafting PM | Regulatory |  | 5.0 | Andrew Margan | Regulatory | Complete | COMPLETE |  |  |  |  |
| 2300 | 1.7.1.2.7.8 | Code drafting for Migration topic area approved | milestone | 0d | 2023-11-22 A | 2023-11-22 A | 2299 | 100% | 2023-11-22 | 2023-11-22 | 0d | 2023-11-13 | 2023-11-13 |  |  | PP | Code Drafting PM | Regulatory |  | 5.12 | Andrew Margan | Regulatory | Complete | COMPLETE | MHHS-ART060 | T3-RE-0400 | CCAG | T2 |
| 2301 | 1.7.1.2.8 | **Consequential Code Change** |  | 109d | 2023-10-11 A | 2024-03-11 A |  | 100% | 2023-10-11 | 2024-03-11 | 108d | 2023-08-18 | 2024-03-08 |  | -0 | N/A | N/A | Regulatory |  | 5.0 | N/A | Regulatory |  |  |  |  |  |  |
| 2302 | 1.7.1.2.8.1 | External industry review via consultation - drop 1 (DCUSA) |  | 15d | 2023-10-11 A | 2023-10-31 A | 2308SS | 100% | 2023-10-11 | 2023-10-31 | 15d | 2023-08-18 | 2023-09-07 |  |  | Code Bodies | PP | Regulatory |  | 5.2 | Andrew Margan | Regulatory | Complete | COMPLETE |  |  |  |  |
| 2303 | 1.7.1.2.8.2 | External industry review via consultation - drop 2 (Elexon) |  | 16d | 2024-02-19 A | 2024-03-11 A | 2318SS | 100% | 2024-02-19 | 2024-03-11 | 15d | 2023-10-16 | 2023-11-03 | start no earlier than 2024-02-19 |  | Code Bodies | PP | Regulatory |  | 5.2 | Andrew Margan | Regulatory | Complete | COMPLETE |  |  |  |  |
| 2304 | 1.7.1.2.9 | **Transition Text (all codes)** |  | 118d | 2023-08-11 A | 2024-01-23 A |  | 100% | 2023-08-11 | 2024-01-23 | 119d | 2023-08-11 | 2024-01-25 |  |  | N/A | N/A | Regulatory | M6 | 5.2 | N/A | Regulatory |  |  |  |  |  |  |
| 2305 | 1.7.1.2.9.1 | Pre Code Drafting activities |  | 8d | 2023-08-11 A | 2023-08-22 A | 2306SS-5d | 100% | 2023-08-11 | 2023-08-22 | 8d | 2023-08-11 | 2023-08-17 |  |  | Code Drafting PM |  | Regulatory |  | 5.0 | Andrew Margan | Regulatory | Complete | COMPLETE |  |  |  |  |
| 2306 | 1.7.1.2.9.2 | Code Drafting (offline) |  | 38d | 2023-08-18 A | 2023-10-10 A | 2296SS | 100% | 2023-08-18 | 2023-10-10 | 38d | 2023-08-18 | 2023-10-12 |  |  | Code Bodies,SRO Design | Code Drafting PM | Regulatory |  | 5.2 | Andrew Margan | Regulatory | Complete | COMPLETE |  |  |  |  |
| 2307 | 1.7.1.2.9.3 | Internal review and cross-checking of drafting across code drafters |  | 28d | 2023-09-01 A | 2023-10-10 A | 2306SS+10d | 100% | 2023-09-01 | 2023-10-10 | 28d | 2023-09-01 | 2023-10-12 |  |  | Code Bodies,SRO Design | Code Drafting PM | Regulatory |  | 5.2 | Andrew Margan | Regulatory | Complete | COMPLETE |  |  |  |  |
| 2308 | 1.7.1.2.9.4 | External industry review via consultation |  | 15d | 2023-10-11 A | 2023-10-31 A | 2307 | 100% | 2023-10-11 | 2023-10-31 | 15d | 2023-10-16 | 2023-11-03 |  |  | PP | Code Drafting PM | Regulatory |  | 5.2 | Andrew Margan | Regulatory | Complete | COMPLETE |  |  |  |  |
| 2309 | 1.7.1.2.9.5 | Triage and action comments |  | 20d | 2023-10-30 A | 2023-11-24 A | 2308FS-2d | 100% | 2023-10-30 | 2023-11-24 | 20d | 2023-11-02 | 2023-11-21 |  |  | Code Bodies,SRO Design | Code Drafting PM | Regulatory |  | 5.2 | Andrew Margan | Regulatory | Complete | COMPLETE |  |  |  |  |
| 2310 | 1.7.1.2.9.6 | CDWG review |  | 37d | 2023-11-27 A | 2024-01-16 A | 2309 | 100% | 2023-11-27 | 2024-01-16 | 37d | 2023-11-22 | 2024-01-17 |  |  | PP | Code Drafting PM | Regulatory |  | 5.2 | Andrew Margan | Regulatory | Complete | COMPLETE |  |  |  |  |
| 2311 | 1.7.1.2.9.7 | CCAG review |  | 5d | 2024-01-17 A | 2024-01-23 A | 2310 | 100% | 2024-01-17 | 2024-01-23 | 6d | 2024-01-18 | 2024-01-25 |  |  | PP | Code Drafting PM | Regulatory |  | 5.2 | Andrew Margan | Regulatory | Complete | COMPLETE |  |  |  |  |
| 2312 | 1.7.1.2.9.8 | Code drafting for Transition Text topic area approved | milestone | 0d | 2024-01-23 A | 2024-01-23 A | 2311 | 100% | 2024-01-23 | 2024-01-23 | 0d | 2024-01-25 | 2024-01-25 |  |  | PP | Code Drafting PM | Regulatory |  | 5.16 | Andrew Margan | Regulatory | Complete | COMPLETE | MHHS-ART060 | T3-RE-0450 | CCAG | T2 |

Notes:
- 2306: Guidance: 14/8/23 - RECCo transition drafting activity is expected to take the full 38 days, noting BSE co-drafting will be expected to take approx. 21 days

| ID | WBS | Task | Type | Duration | Start | Finish | Predecessors | Complete | Remaining | Baseline start | Baseline finish | Baseline duration | Baseline 1 start | Baseline 1 finish | Total slack | Free slack | Baseline cost | Responsible | Involved | Text9 | Task Status | Update Version | MHHS Resource Name | MHHS Programme Phase | Sched Status | RAG | Artefact ID | Milestone ID | Text29 | Tier |
| --- | --- | --- | --- | --- | --- | --- | --- | --- | --- | --- | --- | --- | --- | --- | --- | --- | --- | --- | --- | --- | --- | --- | --- | --- | --- | --- | --- | --- | --- | --- |
| 2313 | 1.7.1.2.10 | **Final Code Drafting (mop-up) (all codes)** |  | 199d | 2023-08-18 A | 2024-05-22 A |  | 100% |  | 2023-08-18 | 2024-05-22 | 199d | 2023-08-18 | 2024-05-13 |  |  |  | N/A | N/A | Regulatory | M6 | 5.0 | N/A | Regulatory |  |  |  |  |  |  |
| 2314 | 1.7.1.2.10.1 | Forward look and confirm remaining plan |  | 15d | 2023-08-18 A | 2023-09-07 A | 2306SS | 100% |  | 2023-08-18 | 2023-09-07 | 15d | 2023-08-18 | 2023-09-07 |  |  |  | Code Drafting PM |  | Regulatory |  | 5.0 | Andrew Margan | Regulatory | Complete | COMPLETE |  |  |  |  |
| 2315 | 1.7.1.2.10.2 | Identify remaining or additional areas of code (e.g. consequential change requirements) to be completed |  | 15d | 2023-08-18 A | 2023-09-07 A | 2314SS | 100% |  | 2023-08-18 | 2023-09-07 | 15d | 2023-08-18 | 2023-09-07 |  |  |  | Code Bodies,SRO Design | Code Drafting PM | Regulatory |  | 5.0 | Andrew Margan | Regulatory | Complete | COMPLETE |  |  |  |  |
| 2316 | 1.7.1.2.10.3 | Code Drafting (offline) Interim Consultation (1) |  | 60d | 2023-09-08 A | 2023-11-30 A | 2315 | 100% |  | 2023-09-08 | 2023-11-30 | 60d | 2023-09-08 | 2024-02-15 |  |  |  | Code Bodies,SRO Design | Code Drafting PM | Regulatory |  | 5.0 | Andrew Margan | Regulatory | Complete | COMPLETE |  |  |  |  |
| 2317 | 1.7.1.2.10.4 | Internal review and cross-checking of drafting across code drafters Interim Consultation (1) |  | 50d | 2023-09-22 A | 2023-11-30 A | 2316SS+10d | 100% |  | 2023-09-22 | 2023-11-30 | 50d | 2023-09-22 | 2024-02-15 |  |  |  | Code Bodies,SRO Design | Code Drafting PM | Regulatory |  | 5.0 | Andrew Margan | Regulatory | Complete | COMPLETE |  |  |  |  |
| 2318 | 1.7.1.2.10.5 | External industry review via consultation Interim Consultation (1) |  | 23d | 2023-12-01 A | 2024-01-02 A | 2317 | 100% |  | 2023-12-01 | 2024-01-02 | 23d | 2024-02-19 | 2024-03-08 |  |  |  | PP | Code Drafting PM | Regulatory |  | 5.0 | Andrew Margan | Regulatory | Complete | COMPLETE |  |  |  |  |
| 2319 | 1.7.1.2.10.6 | Code Drafting (offline) Final Consultation (2) |  | 55d | 2023-12-01 A | 2024-02-15 A | 2317 | 100% |  | 2023-12-01 | 2024-02-15 | 55d | 2023-09-08 | 2024-02-15 |  |  |  | Code Bodies,SRO Design | Code Drafting PM | Regulatory |  | 5.0 | Andrew Margan | Regulatory | Complete | COMPLETE |  |  |  |  |
| 2320 | 1.7.1.2.10.7 | Internal review and cross-checking of drafting across code drafters Final Consultation (2) |  | 45d | 2023-12-15 A | 2024-02-15 A | 2319SS+10d | 100% |  | 2023-12-15 | 2024-02-15 | 45d | 2023-09-22 | 2024-02-15 |  |  |  | Code Bodies,SRO Design | Code Drafting PM | Regulatory |  | 5.0 | Andrew Margan | Regulatory | Complete | COMPLETE |  |  |  |  |
| 2321 | 1.7.1.2.10.8 | External industry review via consultation Final Consultation (2) |  | 16d | 2024-02-19 A | 2024-03-11 A | 2320FS+1d | 100% |  | 2024-02-19 | 2024-03-11 | 15d | 2024-02-19 | 2024-03-08 |  |  |  | PP | Code Drafting PM | Regulatory |  | 5.0 | Andrew Margan | Regulatory | Complete | COMPLETE |  |  |  |  |
| 2322 | 1.7.1.2.10.9 | Triage and action comments |  | 18d | 2024-03-11 A | 2024-04-03 A | 2321FS-1d | 100% |  | 2024-03-11 | 2024-04-03 | 18d | 2024-03-07 | 2024-04-03 |  |  |  | Code Bodies,SRO Design | Code Drafting PM | Regulatory |  | 5.0 | Andrew Margan | Regulatory | Complete | COMPLETE |  |  |  |  |
| 2323 | 1.7.1.2.10.10 | CDWG review |  | 29d | 2024-04-04 A | 2024-05-14 A | 2322 | 100% |  | 2024-04-04 | 2024-05-14 | 31d | 2024-04-04 | 2024-05-03 |  |  |  | PP | Code Drafting PM | Regulatory |  | 5.0 | Andrew Margan | Regulatory | Complete | COMPLETE |  |  |  |  |
| 2324 | 1.7.1.2.10.11 | CCAG review |  | 6d | 2024-05-15 A | 2024-05-22 A | 2323 | 100% |  | 2024-05-15 | 2024-05-22 | 6d | 2024-05-06 | 2024-05-13 |  |  |  | PP | Code Drafting PM | Regulatory |  | 5.0 | Andrew Margan | Regulatory | Complete | COMPLETE |  |  |  |  |
| 2325 | 1.7.1.2.10.12 | Final code drafting (mop-up) approved | milestone | 0d | 2024-05-22 A | 2024-05-22 A | 2324 | 100% |  | 2024-05-22 | 2024-05-22 | 0d | 2024-05-13 | 2024-05-13 |  |  |  | PP | Code Drafting PM | Regulatory |  | 5.25 | Andrew Margan | Regulatory | Complete | COMPLETE | MHHS-ART060 | T3-RE-0500 | CCAG | T2 |
| 2326 | 1.7.1.2.11 | **Final code review, consistency check and approval** |  | 100d | 2024-04-04 A | 2024-08-21 A |  | 100% |  | 2024-04-04 | 2024-08-21 | 102d | 2024-05-06 | 2024-08-23 |  |  | -0 | N/A | N/A | Regulatory | M6 | 5.0 | N/A | Regulatory |  |  |  |  |  |  |
| 2327 | 1.7.1.2.11.1 | Gap analysis of final code against design artefacts (reverse process to code drafting) |  | 38d | 2024-04-04 A | 2024-05-27 A | 2323SS | 100% |  | 2024-04-04 | 2024-05-27 | 38d | 2024-05-06 | 2024-05-17 |  |  |  | Code Bodies,SRO Design | Code Drafting PM | Regulatory |  | 5.0 | Andrew Margan | Regulatory | Complete | COMPLETE |  |  |  |  |
| 2328 | 1.7.1.2.11.2 | Outputs of gap analysis actioned offline |  | 11d | 2024-05-28 A | 2024-06-11 A | 2327 | 100% |  | 2024-05-28 | 2024-06-11 | 11d | 2024-05-20 | 2024-06-07 |  |  |  | Code Bodies,SRO Design | Code Drafting PM | Regulatory |  | 5.0 | Andrew Margan | Regulatory | Complete | COMPLETE |  |  |  |  |
| 2329 | 1.7.1.2.11.3 | Final documentation collated for final consultation |  | 8d | 2024-06-12 A | 2024-06-21 A | 2328 | 100% |  | 2024-06-12 | 2024-06-21 | 9d | 2024-06-10 | 2024-06-13 |  |  |  | Code Drafting PM | Code Bodies,SRO Design | Regulatory |  | 5.23 | Andrew Margan | Regulatory | Complete | COMPLETE |  |  |  |  |
| 2330 | 1.7.1.2.11.4 | External industry review via consultation |  | 15d | 2024-06-24 A | 2024-07-12 A | 2329 | 100% |  | 2024-06-24 | 2024-07-12 | 20d | 2024-06-14 | 2024-07-04 |  |  |  | PP | Code Drafting PM | Regulatory |  | 5.0 | Andrew Margan | Regulatory | Complete | COMPLETE |  |  |  |  |
| 2331 | 1.7.1.2.11.5 | Triage and action comments |  | 10d | 2024-07-15 A | 2024-07-26 A | 2330 | 100% |  | 2024-07-15 | 2024-07-26 | 13d | 2024-07-03 | 2024-07-19 |  |  |  | Code Bodies,SRO Design | Code Drafting PM | Regulatory |  | 5.0 | Andrew Margan | Regulatory | Complete | COMPLETE |  |  |  |  |
| 2332 | 1.7.1.2.11.6 | Final CDWG review |  | 8d | 2024-08-02 A | 2024-08-13 A | 2331FS+4d | 100% |  | 2024-08-02 | 2024-08-13 | 6d | 2024-07-22 | 2024-08-16 |  |  |  | PP | Code Drafting PM | Regulatory |  | 5.0 | Andrew Margan | Regulatory | Complete | COMPLETE |  |  |  |  |
| 2333 | 1.7.1.2.11.7 | Final CCAG review |  | 6d | 2024-08-14 A | 2024-08-21 A | 2332 | 100% |  | 2024-08-14 | 2024-08-21 | 8d | 2024-08-19 | 2024-08-23 |  |  |  | PP | Code Drafting PM | Regulatory |  | 5.0 | Andrew Margan | Regulatory | Complete | COMPLETE |  |  |  |  |
| 2334 | 1.7.1.2.11.8 | CCAG recommend final code to PSG for baselining | milestone | 0d | 2024-08-21 A | 2024-08-21 A | 2333 | 100% |  | 2024-08-21 | 2024-08-21 | 0d | 2024-08-23 | 2024-08-23 |  |  |  | PP | Code Drafting PM | Regulatory |  | 5.9 | Andrew Margan | Regulatory | Complete | COMPLETE | MHHS-ART060 | T3-RE-0550 | CCAG | T2 |
| 2335 | 1.7.1.3 | Code changes baselined (M6) | milestone | 0d | 2024-08-23 A | 2024-08-23 A | 2333FS+2d, 2325, 2312, 2300, 2291, 2282, 2273, 2264, 2255, 2246 | 100% |  | 2024-08-23 | 2024-08-23 | 0d | 2024-08-23 | 2024-08-23 |  |  |  | CPT | PP | Regulatory |  | 5.0 | Andrew Margan | Regulatory | Complete | COMPLETE | MHHS-ART012 | T1-RE-1000 | PSG | T1 |
| 2336 | 1.7.2 | **Ofgem preparation and enactment of SCR powers** |  | 225d | 2024-02-05 A | 2024-12-13 |  | 92% | 17.36d | 2024-02-05 | 2024-12-13 | 225d | 2024-01-26 | 2024-11-12 | 789d |  | -0 | N/A | N/A | Regulatory | M7 | 5.0 | N/A | Regulatory |  |  |  |  |  |  |
| 2337 | 1.7.2.1 | **Preparation and enactment of SCR Powers** |  | 223d | 2024-02-05 A | 2024-12-11 |  | 93% | 15.4d | 2024-02-05 | 2024-12-11 | 223d | 2024-01-26 | 2024-11-11 | 791d |  | -0 | N/A | N/A | Regulatory |  | 5.0 | N/A | Regulatory |  |  |  |  |  |  |
| 2338 | 1.7.2.1.1 | Ofgem to keep Ofgem legal informed of process followed and nature of Code drafting to ensure that prepared for SCR go/no go decision |  | 101d | 2024-02-05 A | 2024-06-24 A | 2339SF | 100% |  | 2024-02-05 | 2024-06-24 | 101d | 2024-01-26 | 2024-06-14 |  |  |  | Ofgem | Code Bodies | Regulatory |  | 5.0 | Andrew Margan | Regulatory | Complete | COMPLETE |  |  |  |  |
| 2339 | 1.7.2.1.2 | OFGEM Legal to review Code Artefacts deliver policy intent and process followed and confirm that SCR powers are appropriate to use rather than SMAP - SCR go/no go |  | 14d | 2024-06-24 A | 2024-07-11 A | 2330SS | 100% |  | 2024-06-24 | 2024-07-11 | 15d | 2024-06-14 | 2024-07-04 |  |  |  | Ofgem | Code Bodies | Regulatory |  | 5.0 | Andrew Margan | Regulatory | Complete | COMPLETE |  |  |  |  |
| 2340 | 1.7.2.1.3 | Code Bodies to draft MOD proposal forms |  | 20d | 2024-07-12 A | 2024-08-08 A | 2339 | 100% |  | 2024-07-12 | 2024-08-08 | 20d | 2024-07-05 | 2024-08-01 |  |  |  | Code Bodies | Ofgem | Regulatory |  | 5.0 | Andrew Margan | Regulatory | Complete | COMPLETE |  |  |  |  |
| 2341 | 1.7.2.1.4 | Ofgem discuss and agree code mod timetable with code bodies (and MHHSP in relation to the dates for expected decisions) |  | 20d | 2024-07-12 A | 2024-08-08 A | 2339 | 100% |  | 2024-07-12 | 2024-08-08 | 20d | 2024-07-05 | 2024-08-01 |  |  |  | Ofgem | Code Bodies | Regulatory |  | 5.0 | Andrew Margan | Regulatory | Complete | COMPLETE |  |  |  |  |
| 2342 | 1.7.2.1.5 | Ofgem to publish each Direction to each code body specifying the timetable for each modification |  | 1d | 2024-08-28 A | 2024-08-28 A | 2341FS+13d | 100% |  | 2024-08-28 | 2024-08-28 | 1d | 2024-08-28 | 2024-08-28 |  |  |  | Ofgem | Code Bodies | Regulatory |  | 5.0 | Andrew Margan | Regulatory | Complete | COMPLETE |  |  |  |  |
| 2343 | 1.7.2.1.6 | Formally submit (by separate email) Modification Proposal Forms and legal texts to each code body |  | 1d | 2024-08-28 A | 2024-08-28 A | 2341FS+13d | 100% |  | 2024-08-28 | 2024-08-28 | 1d | 2024-08-28 | 2024-08-28 |  |  |  | Ofgem | Code Bodies | Regulatory |  | 5.0 | Andrew Margan | Regulatory | Complete | COMPLETE |  |  |  |  |
| 2344 | 1.7.2.1.7 | Each Code Body publishes and issues Modification Proposal Forms |  | 3d | 2024-08-29 A | 2024-09-02 A | 2343, 2342 | 100% |  | 2024-08-29 | 2024-09-02 | 3d | 2024-08-29 | 2024-09-02 |  |  |  | Code Bodies | Ofgem | Regulatory |  | 5.0 | Andrew Margan | Regulatory | Complete | COMPLETE |  |  |  |  |
| 2345 | 1.7.2.1.8 | Each Code Body sends Modification Proposal Forms to Panel to approve Mod to go to consultation |  | 10d | 2024-09-03 A | 2024-09-16 A | 2344 | 100% |  | 2024-09-03 | 2024-09-16 | 10d | 2024-09-03 | 2024-09-16 |  |  |  | Code Bodies | Ofgem | Regulatory |  | 5.0 | Andrew Margan | Regulatory | Complete | COMPLETE |  |  |  |  |
| 2346 | 1.7.2.1.9 | Modification Proposal approved by Panel for Consultation |  | 1d | 2024-09-17 A | 2024-09-17 A | 2345 | 100% |  | 2024-09-17 | 2024-09-17 | 1d | 2024-09-17 | 2024-09-17 |  |  |  | Code Bodies | Ofgem | Regulatory |  | 5.0 | Andrew Margan | Regulatory | Complete | COMPLETE |  |  |  |  |
| 2347 | 1.7.2.1.10 | Draft Modification Report issued for consultation |  | 1d | 2024-09-18 A | 2024-09-18 A | 2346 | 100% |  | 2024-09-18 | 2024-09-18 | 1d | 2024-09-18 | 2024-09-18 |  |  |  | Code Bodies | Ofgem | Regulatory |  | 5.0 | Andrew Margan | Regulatory | Complete | COMPLETE |  |  |  |  |
| 2348 | 1.7.2.1.11 | Consultation Close-out for representations |  | 15d | 2024-09-19 A | 2024-10-09 A | 2347 | 100% |  | 2024-09-19 | 2024-10-09 | 15d | 2024-09-19 | 2024-10-09 |  |  |  | Code Bodies | Ofgem | Regulatory |  | 5.0 | Andrew Margan | Regulatory | Complete | COMPLETE |  |  |  |  |
| 2349 | 1.7.2.1.12 | Each Code Body reviews consultation response and drafts Modification Report |  | 10d | 2024-10-10 A | 2024-10-23 A | 2348 | 100% |  | 2024-10-10 | 2024-10-23 | 10d | 2024-10-10 | 2024-10-23 |  |  |  | Code Bodies | Ofgem | Regulatory |  | 5.0 | Andrew Margan | Regulatory | Complete | COMPLETE |  |  |  |  |
| 2350 | 1.7.2.1.13 | Final Modification Report sent to Panel for decision with recommendation to approve |  | 1d | 2024-10-24 A | 2024-10-24 A | 2349 | 100% |  | 2024-10-24 | 2024-10-24 | 1d | 2024-10-24 | 2024-10-24 |  |  |  | Code Bodies | Ofgem | Regulatory |  | 6.11 | Andrew Margan | Regulatory | Complete | COMPLETE |  |  |  |  |
| 2351 | 1.7.2.1.14 | Modification Panel decision |  | 1d | 2024-11-07 A | 2024-11-07 A | 2350FS+9d | 100% |  | 2024-11-07 | 2024-11-07 | 1d | 2024-11-07 | 2024-11-07 |  |  |  | Code Bodies | Ofgem | Regulatory |  | 6.11 | Andrew Margan | Regulatory | Complete | COMPLETE |  |  |  |  |
| 2352 | 1.7.2.1.15 | Code Bodies Submit Final Modification/Change Reports |  | 1d | 2024-11-08 A | 2024-11-08 A | 2351 | 100% |  | 2024-11-08 | 2024-11-08 | 1d |  |  |  |  |  | Code Bodies | Ofgem | Regulatory |  | 6.11 | Andrew Margan |  | Complete | COMPLETE |  |  |  |  |
| 2353 | 1.7.2.1.16 | Ofgem Reviews Final Modification/Change Reports |  | 10d | 2024-11-11 A | 2024-11-22 | 2352 | 80% | 2d | 2024-11-11 | 2024-11-22 | 10d |  |  | 804d | 0d |  | Ofgem | Code Bodies | Regulatory |  | 6.11 | Andrew Margan |  | Green | RED |  |  |  |  |
| 2354 | 1.7.2.1.17 | Ofgem Drafts Decision/Direction Letters |  | 17d | 2024-11-18 A | 2024-12-10 | 2353SS+5d | 25% | 12.75d | 2024-11-18 | 2024-12-10 | 17d |  |  | 726d | 0d |  | Ofgem | Code Bodies | Regulatory |  | 6.11 | Andrew Margan |  | Green | GREEN |  |  |  |  |
| 2355 | 1.7.2.1.18 | Ofgem Internally Signs Off the Decision/Direction Letters and Sends Them to the Code Bodies |  | 1d | 2024-12-11 | 2024-12-11 | 2354 |  |  | 2024-12-11 | 2024-12-11 | 1d |  |  | 726d | 0d |  | Ofgem | Code Bodies | Regulatory | 14.33 | 6.11 | Andrew Margan |  | Green | GREEN |  |  |  |  |
| 2356 | 1.7.2.2 | Ofgem decisions on M6 baselined code modification proposals (M7) | milestone | 0d | 2024-12-11 | 2024-12-11 | 2335, 2355 |  |  | 2024-12-11 | 2024-12-11 | 0d | 2024-11-11 | 2024-11-11 | 726d | 0d |  | CPT | PP | Regulatory | 14.71 | 6.11 | Andrew Margan | Regulatory | Green | GREEN | MHHS-ART012 | T2-RE-0600 | CCAG | T2 |
| 2357 | 1.7.2.3 | Ofgem Publishes the Decisions/Directions |  | 2d | 2024-12-12 | 2024-12-13 | 2356 |  |  | 2024-12-12 | 2024-12-13 | 2d |  |  | 789d |  |  | Ofgem | Code Bodies | Regulatory | 15.33 | 6.11 | Andrew Margan |  | Green | GREEN |  |  |  |  |

Notes:
- 2350: 28/10/24 - Code Bodies continue to lead on the SCR process and will be submitting their FMRs in due course.
- 2353: 25/11/24 - Programme believes this is complete, but this hasn't been formally confirmed with Ofgem. Successor activity is underway and unaffected by this RAG.
- 2356: Guidance: 5/8/25 - CR no52 and going to PSG on 7/8/24. 21/8/24: Milestone name and date change approved at psg on 7/8/24

| ID | WBS | Task | Type | Duration | Start | Finish | Predecessors | Complete | Remaining | Baseline start | Baseline finish | Baseline duration | Baseline 1 start | Baseline 1 finish | Total slack | Free slack | Constraint | Baseline cost | Responsible | Involved | Text9 | Task Status | Update Version | MHHS Resource Name | MHHS Programme Phase | Sched Status | RAG | Artefact ID | Milestone ID | Text29 | Tier | Future RAG |
| --- | --- | --- | --- | --- | --- | --- | --- | --- | --- | --- | --- | --- | --- | --- | --- | --- | --- | --- | --- | --- | --- | --- | --- | --- | --- | --- | --- | --- | --- | --- | --- | --- |
| 2358 | 1.7.3 | **Deliver MHHS Code Changes** |  | 291d | 2024-11-12 A | 2025-12-23 |  | 84% | 47.81d | 2024-11-12 | 2025-12-24 | 149d | 2024-11-12 | 2025-03-07 | 522d |  |  |  | N/A | N/A | Regulatory | M8 | 6.11 | N/A | Regulatory |  |  |  |  |  |  |  |
| 2359 | 1.7.3.1 | **Releases** |  | 291d | 2024-11-12 A | 2025-12-23 |  | 84% | 47.81d | 2024-11-12 | 2025-12-24 | 149d | 2024-11-12 | 2025-03-07 | 522d |  |  |  | N/A | N/A | Regulatory |  | 6.11 | N/A | Regulatory |  |  |  |  |  |  |  |
| 2360 | 1.7.3.1.1 | Impacted codes make resourcing provisions and prepare to implement new Code via internal code body change processes |  | 78d | 2024-11-12 A | 2025-02-27 |  | 90% | 7.8d | 2024-11-12 | 2025-02-27 | 78d | 2024-11-12 | 2025-02-27 | 735d |  | start no earlier than 2024-11-12 |  | Code Bodies |  | Regulatory |  | 6.11 | Andrew Margan | Regulatory | Green | GREEN |  |  |  |  |  |
| 2361 | 1.7.3.1.2 | **Main Code Release** |  | 71d | 2025-09-16 | 2025-12-23 |  |  |  | 2025-09-17 | 2025-12-24 | 71d | 2025-02-28 | 2025-03-07 | 522d |  |  |  | N/A | N/A | Regulatory |  | 6.11 | N/A | Regulatory |  |  |  |  |  |  |  |
| 2362 | 1.7.3.1.2.1 | Release preparation (e.g. preparing release documentation) |  | 6d | 2025-09-16 | 2025-09-23 | 2363SF |  |  | 2025-09-17 | 2025-09-24 | 5d | 2025-02-28 | 2025-03-07 | 587d |  |  |  | Code Bodies |  | Regulatory | 293.33 | 6.11 | Andrew Margan | Regulatory | Green | GREEN |  |  |  |  |  |
| 2363 | 1.7.3.1.2.2 | Implement new code on day of code release | milestone | 0d | 2025-09-23 | 2025-09-23 | 2364SF |  |  | 2025-09-24 | 2025-09-24 | 1d | 2025-03-07 | 2025-03-07 | 587d | 0d |  |  | Code Bodies |  | Regulatory | 300.71 | 6.11 | Andrew Margan | Regulatory | Green | GREEN |  |  |  |  |  |
| 2364 | 1.7.3.1.2.3 | Code changes delivered (M8) | milestone | 0d | 2025-09-23 | 2025-09-23 | 2356, 2335, 1712SS |  |  | 2025-09-24 | 2025-09-24 | 0d | 2025-03-07 | 2025-03-07 | 522d | 0d |  |  | CPT | Code Bodies,PP | Regulatory | 300.71 | 6.11 | Andrew Margan | Regulatory | Green | GREEN | MHHS-ART060 | T2-RE-0650 | CCAG | T2 |  |
| 2365 | 1.7.3.1.2.4 | Code changes delivered (M8*) late exit | milestone | 0d | 2025-12-23 | 2025-12-23 | 2364FS+65d |  |  | 2025-12-24 | 2025-12-24 | 0d |  |  | 522d |  |  |  | CPT | Code Bodies,PP | Regulatory | 391.71 | 6.11 | Andrew Margan | Regulatory | Green | GREEN | MHHS-ART060 | T2-RE-0700 | CCAG | T2 |  |
| 2366 | 1.7.4 | **External Programme Dependency Management** |  | 38d | 2023-12-01 A | 2024-01-24 A |  | 100% |  | 2023-12-01 | 2024-01-24 | 38d | 2023-09-08 | 2024-01-24 |  |  |  |  | N/A | N/A | Regulatory |  | 5.0 | N/A | Regulatory |  |  |  |  |  |  |  |
| 2367 | 1.7.4.1 | **DCP397** |  | 38d | 2023-12-01 A | 2024-01-24 A |  | 100% |  | 2023-12-01 | 2024-01-24 | 38d | 2023-09-08 | 2024-01-24 |  |  |  |  | N/A | N/A | Regulatory |  | 5.0 | N/A | Regulatory |  |  |  |  |  |  |  |
| 2368 | 1.7.4.1.1 | Ensure DCP397 drafting included in mop-up code drafting activity (link to mop-up) |  | 20d | 2023-12-01 A | 2023-12-28 A | 2319SS, 2316SS | 100% |  | 2023-12-01 | 2023-12-28 | 20d | 2023-09-08 | 2023-10-05 |  |  |  |  | CPT | Code Bodies,SRO Design, Code Drafting PM | Regulatory |  | 5.0 | Andrew Margan | Regulatory | Complete | COMPLETE |  |  |  |  |  |
| 2369 | 1.7.4.1.2 | Implementation of DCP397 | milestone | 0d | 2024-01-24 A | 2024-01-24 A |  | 100% |  | 2024-01-24 | 2024-01-24 | 0d | 2024-01-24 | 2024-01-24 |  |  | start no earlier than 2024-01-24 |  | Code Bodies |  | Regulatory |  | 5.0 | Andrew Margan | Regulatory | Complete | COMPLETE |  |  |  |  |  |
| 2370 | 1.8 | **MIGRATION** |  | 1246d | 2022-10-31 A | 2027-08-09 |  | 39% | 762.12d | 2022-10-31 | 2027-08-09 | 1092d | 2022-10-31 | 2027-01-05 | 98d |  |  | -0 | N/A | N/A | Migration |  |  | N/A | Migration |  |  |  |  |  |  | 1 Oct 2024 - 31 Oct 2025 |
| 2371 | 1.8.1 | Migration Period Plan Review 1 Completed | milestone | 0d | 2025-01-31 | 2025-01-31 |  |  |  | 2025-01-31 | 2025-01-31 | 0d | 2025-01-31 | 2025-01-31 | 754d |  | finish no earlier than 2025-01-31 |  | SRO | PP,IPA | Migration | 65.71 | 5.28 | Simon chidwick | Migration | Green | GREEN |  | T3-MI-0016 | MCAG (Migration) | T3 |  |
| 2372 | 1.8.2 | **Regulatory Governance** |  | 198d | 2024-04-01 A | 2025-01-01 |  | 47% | 105d | 2024-04-01 | 2025-01-01 | 173d |  |  | 776d |  |  | -0 | N/A | N/A | Migration |  | 5.28 | N/A |  |  |  |  |  |  |  |  |
| 2373 | 1.8.2.1 | Incentive Mods Created |  | 110d | 2024-04-01 A | 2024-08-30 |  | 85% | 17d | 2024-04-01 | 2024-08-30 | 85d |  |  | 776d | 0d | start no earlier than 2024-04-01 |  | SRO Migration | SRO Migration,Code Bodies,PP | Migration |  | 5.28 | Simon chidwick |  | Overdue | RED |  |  |  |  |  |
| 2374 | 1.8.2.2 | Incentives Implemented |  | 88d | 2024-09-02 | 2025-01-01 | 2373 |  |  | 2024-09-02 | 2025-01-01 | 88d |  |  | 776d |  | start no earlier than 2024-07-02 |  | Code Bodies | Code Bodies,SRO Migration | Migration | -85.67 | 5.28 | Simon chidwick |  | Overdue Start | GREEN |  |  |  |  |  |
| 2375 | 1.8.3 | **Migration Framework Agreed and Implemented** |  | 256d | 2024-02-01 A | 2025-01-23 |  | 62% | 97.34d | 2024-02-01 | 2025-01-23 | 214d |  |  | 672d |  |  | -0 | N/A | N/A | Migration |  | 5.28 | N/A |  |  |  |  |  |  |  |  |
| 2376 | 1.8.3.1 | **Consultation 1 - Schedule** |  | 70d | 2024-02-01 A | 2024-05-08 A |  | 100% |  | 2024-02-01 | 2024-05-08 | 70d |  |  |  |  |  |  | N/A | N/A | Migration |  | 5.28 | N/A |  |  |  |  |  |  |  |  |
| 2377 | 1.8.3.1.1 | Prepare Artefacts for Consultation |  | 33d | 2024-02-01 A | 2024-03-18 A |  | 100% |  | 2024-02-01 | 2024-03-18 | 33d |  |  |  |  |  |  |  |  | Migration |  | 5.28 | Simon chidwick |  | Complete | COMPLETE |  |  |  |  |  |
| 2378 | 1.8.3.1.2 | Industry Consultation |  | 16d | 2024-03-18 A | 2024-04-08 A |  | 100% |  | 2024-03-18 | 2024-04-08 | 16d |  |  |  |  |  |  |  |  | Migration |  | 5.28 | Simon chidwick |  | Complete | COMPLETE |  |  |  |  |  |
| 2379 | 1.8.3.1.3 | Triage and Action Comments |  | 10d | 2024-04-08 A | 2024-04-19 A |  | 100% |  | 2024-04-08 | 2024-04-19 | 10d |  |  |  |  |  |  |  |  | Migration |  | 5.28 | Simon chidwick |  | Complete | COMPLETE |  |  |  |  |  |
| 2380 | 1.8.3.1.4 | Industry Assurance Review |  | 6d | 2024-04-19 A | 2024-04-26 A |  | 100% |  | 2024-04-19 | 2024-04-26 | 6d |  |  |  |  |  |  |  |  | Migration |  | 5.28 | Simon chidwick |  | Complete | COMPLETE |  |  |  |  |  |
| 2381 | 1.8.3.1.5 | MWG Recommendation |  | 1d | 2024-04-26 A | 2024-04-26 A |  | 100% |  | 2024-04-26 | 2024-04-26 | 1d |  |  |  |  |  |  |  |  | Migration |  | 5.28 | Simon chidwick |  | Complete | COMPLETE |  |  |  |  |  |
| 2382 | 1.8.3.1.6 | MCAG Interim Approval Artefacts |  | 1d | 2024-05-08 A | 2024-05-08 A |  | 100% |  | 2024-05-08 | 2024-05-08 | 1d |  |  |  |  |  |  |  |  | Migration |  | 5.28 | Simon chidwick |  | Complete | COMPLETE |  |  |  |  |  |

Notes:
- 2371: To go to MCAG for removal because milestone no longer reflects the delivery of the migration approach. / Action: 11/7/24: MI-0016 warren is saying he wants another think about before going to MCAG so can you hold off doing anything official with that one please?
- 2373: Potential to extend this to end of the year

| ID | WBS | Task | Type | Duration | Start | Finish | Predecessors | Complete | Remaining | Baseline start | Baseline finish | Baseline duration | Total slack | Free slack | Baseline cost | Responsible | Involved | Text9 | Update Version | MHHS Resource Name | Sched Status | RAG | Milestone ID | Text29 | Task Status |
| --- | --- | --- | --- | --- | --- | --- | --- | --- | --- | --- | --- | --- | --- | --- | --- | --- | --- | --- | --- | --- | --- | --- | --- | --- | --- |
| 2383 | 1.8.3.2 | **Consultation 2 - Control** |  | 79d | 2024-04-08 A | 2024-07-25 A |  | 100% |  | 2024-04-08 | 2024-07-25 | 79d |  |  | -0 | N/A | N/A | Migration | 5.28 | N/A |  |  |  |  |  |
| 2384 | 1.8.3.2.1 | Prepare Artefacts for Consultation |  | 49d | 2024-04-08 A | 2024-06-13 A |  | 100% |  | 2024-04-08 | 2024-06-13 | 49d |  |  |  |  |  | Migration | 5.28 | Simon chidwick | Complete | COMPLETE |  |  |  |
| 2385 | 1.8.3.2.2 | Industry Consultation |  | 11d | 2024-06-14 A | 2024-06-28 A | 2384 | 100% |  | 2024-06-14 | 2024-06-28 | 11d |  |  |  |  |  | Migration | 5.28 | Simon chidwick | Complete | COMPLETE |  |  |  |
| 2386 | 1.8.3.2.3 | Triage and Action Comments |  | 9d | 2024-07-01 A | 2024-07-11 A | 2385 | 100% |  | 2024-07-01 | 2024-07-11 | 9d |  |  |  | SRO Migration | SRO Migration | Migration | 5.28 | Simon chidwick | Complete | COMPLETE |  |  |  |
| 2387 | 1.8.3.2.4 | Industry Assurance Review |  | 5d | 2024-07-12 A | 2024-07-18 A | 2386 | 100% |  | 2024-07-12 | 2024-07-18 | 5d |  |  |  | PP | PP,SRO Migration | Migration | 5.28 | Simon chidwick | Complete | COMPLETE |  |  |  |
| 2388 | 1.8.3.2.5 | MWG Recommendation | milestone | 0d | 2024-07-18 A | 2024-07-18 A | 2387 | 100% |  | 2024-07-18 | 2024-07-18 | 0d |  |  |  | PP | PP,SRO Migration | Migration | 5.28 | Simon chidwick | Complete | COMPLETE |  |  |  |
| 2389 | 1.8.3.2.6 | Consultation 2 - Control - MCAG Approval of Interim Artefacts | milestone | 0d | 2024-07-25 A | 2024-07-25 A | 2388FS+5d | 100% |  | 2024-07-25 | 2024-07-25 | 0d |  |  |  | PP | PP,SRO Migration | Migration | 5.30 | Simon chidwick | Complete | COMPLETE | T3-MI-0037 | MCAG (Migration) |  |
| 2390 | 1.8.3.3 | **Consultation 3 - Parameters** |  | 143d | 2024-07-09 A | 2025-01-23 |  | 18% | 117.21d | 2024-07-09 | 2025-01-23 | 76d | 672d |  | -0 | N/A | N/A | Migration | 5.28 | N/A |  |  |  |  |  |
| 2391 | 1.8.3.3.1 | Prepare Artefacts (9) for Consultation |  | 95d | 2024-07-09 A | 2024-11-18 | 2398SS+6d | 23% | 73d | 2024-07-09 | 2024-11-18 | 36d | 672d | 0d |  | SRO Migration | SRO Migration | Migration | 5.28 | Simon chidwick | Green | RED |  |  |  |
| 2392 | 1.8.3.3.2 | Industry Consultation |  | 10d | 2024-11-19 | 2024-12-02 | 2391 |  |  | 2024-11-19 | 2024-12-02 | 10d | 672d | 0d |  | PP | PP,SRO Migration | Migration | 5.28 | Simon chidwick | Green | RED |  |  | -7.67 |
| 2393 | 1.8.3.3.3 | Triage and Action Comments |  | 10d | 2024-12-03 | 2024-12-16 | 2392 |  |  | 2024-12-03 | 2024-12-16 | 10d | 672d | 0d |  | SRO Migration | SRO Migration | Migration | 5.28 | Simon chidwick | Green | RED |  |  | 6.33 |
| 2394 | 1.8.3.3.4 | Industry Assurance Review |  | 7d | 2024-12-17 | 2024-12-25 | 2393 |  |  | 2024-12-17 | 2024-12-25 | 7d | 672d | 0d |  | PP | PP,SRO Migration | Migration | 5.28 | Simon chidwick | Green | RED |  |  | 20.33 |
| 2395 | 1.8.3.3.5 | MWG Recommendation | milestone | 0d | 2025-01-06 | 2025-01-06 | 2394FS+8d |  |  | 2025-01-06 | 2025-01-06 | 0d | 672d | 0d |  | PP | PP,SRO Migration | Migration | 5.28 | Simon chidwick | Green | RED |  |  | 40.71 |
| 2396 | 1.8.3.3.6 | MCAG Approval of Migration Framework Artefacts (Baselined) | milestone | 0d | 2025-01-23 | 2025-01-23 | 2399, 2395FS+13d |  |  | 2025-01-23 | 2025-01-23 | 0d | 672d | 0d |  | PP | PP,SRO Migration | Migration | 5.30 | Simon chidwick | Green | AMBER | T3-MI-0017 | MCAG (Migration) | 57.71 |
| 2397 | 1.8.4 | **Migration Schedule Agreed and Maintained** |  | 415d | 2024-07-01 A | 2026-01-30 |  | 41% | 246.53d | 2024-07-01 | 2026-01-30 | 207d | 494d |  | -0 | N/A | N/A | Migration | 5.28 | N/A |  |  |  |  |  |
| 2398 | 1.8.4.1 | Indicative Envelopes Issued |  | 23d | 2024-07-01 A | 2024-07-31 A | 2382FS+37d | 100% |  | 2024-07-01 | 2024-07-31 | 23d |  |  |  | SRO Migration | SRO Migration,PP | Migration | 5.28 | Simon chidwick | Complete | COMPLETE |  |  |  |
| 2399 | 1.8.4.2 | Supplier Submissions |  | 45d | 2024-08-01 A | 2024-10-02 A | 2398, 2389 | 100% |  | 2024-08-01 | 2024-10-02 | 45d |  |  |  | PP | SRO Migration,PP | Migration | 5.28 | Simon chidwick | Complete | COMPLETE |  |  |  |
| 2400 | 1.8.4.3 | Team Assess Responses |  | 10d | 2024-10-03 A | 2024-10-16 A | 2399 | 100% |  | 2024-10-03 | 2024-10-16 | 10d |  |  |  | SRO Migration | SRO Migration | Migration | 5.28 | Simon chidwick | Complete | COMPLETE |  |  |  |
| 2401 | 1.8.4.4 | Discuss and Agree Approach with Participants where necessary |  | 4d | 2024-10-17 A | 2024-10-22 A | 2400 | 100% |  | 2024-10-17 | 2024-10-22 | 4d |  |  |  | SRO Migration | SRO Migration,PP | Migration | 5.28 | Simon chidwick | Complete | COMPLETE |  |  |  |
| 2402 | 1.8.4.5 | V1.0 of Migration Schedule Baseline Approved at MCAG | milestone | 0d | 2025-01-10 | 2025-01-10 | 2411, 2401 |  |  | 2025-01-10 | 2025-01-10 | 0d | 494d | 0d |  | PP | SRO Migration,PP | Migration | 5.30 | Simon chidwick | Green | GREEN | T3-MI-0039 | MCAG (Migration) | 44.71 |
| 2403 | 1.8.4.6 | Sprint Planning (Cycle 1) |  | 40d | 2025-06-16 | 2025-08-08 | 2402FS+110d |  |  | 2025-06-16 | 2025-08-08 | 20d | 494d | 0d |  | SRO Migration | SRO Migration,PP | Migration | 5.28 | Simon chidwick | Green | GREEN |  |  | 201.33 |
| 2404 | 1.8.4.7 | Sprint Planning (Cycle 2) |  | 40d | 2025-09-15 | 2025-11-07 | 2403FS+25d |  |  | 2025-09-15 | 2025-11-07 | 20d | 494d | 0d |  | SRO Migration | SRO Migration,PP | Migration | 5.28 | Simon chidwick | Green | GREEN |  |  | 292.33 |
| 2405 | 1.8.4.8 | Sprint Planning (Cycle 3) |  | 40d | 2025-12-08 | 2026-01-30 | 2404FS+20d, 2419 |  |  | 2025-12-08 | 2026-01-30 | 19d | 494d |  |  | SRO Migration | SRO Migration,PP | Migration | 5.28 | Simon chidwick | Green | GREEN |  |  | 376.33 |
| 2406 | 1.8.5 | **Migration Control Centre Tooling** |  | 242d | 2024-05-09 A | 2025-04-11 |  | 66% | 81.56d | 2024-05-09 | 2025-04-11 | 182d | 663d |  |  | N/A | N/A | Migration | 5.28 | N/A |  |  |  |  |  |
| 2407 | 1.8.5.1 | Data Source Definition |  | 120d | 2024-05-09 A | 2024-10-23 A | 2382 | 100% |  | 2024-05-09 | 2024-10-23 | 60d |  |  |  | SRO Migration | SRO Migration | Migration | 5.28 | Simon chidwick | Complete | COMPLETE |  |  |  |
| 2408 | 1.8.5.2 | Scheduling and Data Requirements |  | 120d | 2024-05-09 A | 2024-10-23 A | 2382 | 100% |  | 2024-05-09 | 2024-10-23 | 60d |  |  |  | SRO Migration | SRO Migration | Migration | 5.28 | Simon chidwick | Complete | COMPLETE |  |  |  |
| 2409 | 1.8.5.3 | Tool Phase 1 |  | 11d | 2024-10-24 | 2024-11-07 | 2408, 2407 |  |  | 2024-10-24 | 2024-11-07 | 11d | 494d | 0d |  | SRO Migration | SRO Migration | Migration | 5.28 | Simon chidwick | Green | RED |  |  | -33.67 |
| 2410 | 1.8.5.4 | Data Requirements |  | 21d | 2024-11-08 | 2024-12-06 | 2382, 2409 |  |  | 2024-11-08 | 2024-12-06 | 21d | 494d | 0d |  | SRO Migration | SRO Migration | Migration | 5.28 | Simon chidwick | Green | GREEN |  |  | -18.67 |
| 2411 | 1.8.5.5 | Tool Phase 2 |  | 25d | 2024-12-09 | 2025-01-10 | 2410 |  |  | 2024-12-09 | 2025-01-10 | 25d | 494d | 0d |  | SRO Migration | SRO Migration | Migration | 5.28 | Simon chidwick | Green | GREEN |  |  | 12.33 |
| 2412 | 1.8.5.6 | Data Source Provision |  | 7d | 2025-01-13 | 2025-01-21 | 2411 |  |  | 2025-01-13 | 2025-01-21 | 7d | 663d | 0d |  | SRO Migration | SRO Migration | Migration | 5.28 | Simon chidwick | Green | GREEN |  |  | 47.33 |
| 2413 | 1.8.5.7 | Tool - Internal and External Testing |  | 58d | 2025-01-22 | 2025-04-11 | 2412 |  |  | 2025-01-22 | 2025-04-11 | 58d | 663d | 0d |  | SRO Migration | SRO Migration,PP | Migration | 5.28 | Simon chidwick | Green | GREEN |  |  | 56.33 |

Notes:
- 2389: Guidance: 25/7/24: New Milestone approved at MCAG on 25/7/24
- 2391: 29/10/24 - Red rating given because the consultation will take place in December. Exact date for this not yet set.
- 2392: 29/10/24 - Red rating given because the consultation will take place in December. Exact date for this not yet set.
- 2393: 29/10/24 - Red rating given because the consultation will take place in December. Exact date for this not yet set.
- 2394: 29/10/24 - Red rating given because the consultation will take place in December. Exact date for this not yet set.
- 2395: 29/10/24 - Red rating given because the consultation will take place in December. Exact date for this not yet set.
- 2396: 29/10/24 - Expecting the baseline date to change, but approval needed from MCAG before this can happen. This is due to a combination of the changes coming out of MWG for Consultation 3 being very minimal for the original release date of 28th August and not warranting an industry consultation. / Guidance: 25/7/24: Milestone name and date change approved at MCAG on 25/7/24. Date from 2/8/24 to 22/10/24. Name from 'Migration Processes & Procedures approved' to 'MCAG Approval of Migration Framework Artefacts (Baselined)’
- 2402: Guidance: 25/7/24: New Milestone approved at MCAG on 25/7/24
- 2405: Action: 8/7/24: Successor was on M10 (1861 id903) - I removed as it was moving the date out
- 2409: Action: 9/7/24: To be expanded once clarified
- 2410: Action: 9/7/24: To be expanded once clarified
- 2411: Action: 9/7/24: To be expanded once clarified
- 2412: Action: 9/7/24: To be expanded once clarified
- 2413: Action: 9/7/24: To be expanded once clarified

| ID | WBS | Task | Type | Duration | Start | Finish | Predecessors | Complete | Remaining | Baseline start | Baseline finish | Baseline duration | Baseline 1 start | Baseline 1 finish | Total slack | Free slack | Baseline cost | Responsible | Involved | Text9 | Update Version | MHHS Resource Name | Sched Status | RAG | Task Status | MHHS Programme Phase | Artefact ID | Milestone ID | Text29 | Tier |
| --- | --- | --- | --- | --- | --- | --- | --- | --- | --- | --- | --- | --- | --- | --- | --- | --- | --- | --- | --- | --- | --- | --- | --- | --- | --- | --- | --- | --- | --- | --- |
| 2414 | 1.8.6 | **Migration Control Centre Mobilised and Ready** |  | 185d | 2024-07-30 A | 2025-04-14 |  | 1% | 182.8d | 2024-07-30 | 2025-04-14 | 134d |  |  | 663d |  |  | N/A | N/A | Migration | 5.28 | N/A |  |  |  |  |  |  |  |  |
| 2415 | 1.8.6.1 | Migration Control Centre TOM Definition |  | 65d | 2024-07-30 A | 2024-10-28 | 2389FS+2d | 3% | 63d | 2024-07-30 | 2024-10-28 | 29d |  |  | 677d | 0d |  | SRO Migration | SRO Migration | Migration | 5.28 | Simon chidwick | Green | GREEN |  |  |  |  |  |  |
| 2416 | 1.8.6.2 | Access to Data |  | 25d | 2024-11-04 | 2024-12-06 | 2415FS+4d |  |  | 2024-11-04 | 2024-12-06 | 25d |  |  | 677d | 0d |  | SRO Migration | SRO Migration | Migration | 5.28 | Simon chidwick | Green | GREEN | -22.67 |  |  |  |  |  |
| 2417 | 1.8.6.3 | Migration Control Centre Delegation of Authority |  | 12d | 2024-12-24 | 2025-01-08 | 2416FS+11d |  |  | 2024-12-24 | 2025-01-08 | 12d |  |  | 677d | 0d |  | SRO Migration | SRO Migration | Migration | 5.28 | Simon chidwick | Green | GREEN | 27.33 |  |  |  |  |  |
| 2418 | 1.8.6.4 | Recruit and Train |  | 65d | 2024-12-24 | 2025-03-24 | 2417SS |  |  | 2024-12-24 | 2025-03-24 | 65d |  |  | 677d | 14d |  | SRO Migration | SRO Migration | Migration | 5.28 | Simon chidwick | Green | GREEN | 27.33 |  |  |  |  |  |
| 2419 | 1.8.6.5 | Dress Rehearsal |  | 1d | 2025-04-14 | 2025-04-14 | 2413, 2418, 2423, 2424 |  |  | 2025-04-14 | 2025-04-14 | 1d |  |  | 663d | 169d |  | SRO Migration | SRO Migration | Migration | 5.28 | Simon chidwick | Green | GREEN | 138.33 |  |  |  |  |  |
| 2420 | 1.8.7 | **PP's Prepared for Migration** |  | 196d | 2024-07-01 A | 2025-03-31 |  | 23% | 150.77d | 2024-07-01 | 2025-03-31 | 154d |  |  | 672d |  | -0 | N/A | N/A | Migration | 5.28 | N/A |  |  |  |  |  |  |  |  |
| 2421 | 1.8.7.1 | Prep for Envelope Webinar |  | 26d | 2024-07-01 A | 2024-08-05 A | 2398SS | 100% |  | 2024-07-01 | 2024-08-05 | 26d |  |  |  |  |  | SRO Migration | SRO Migration | Migration | 5.28 | Simon chidwick | Complete | COMPLETE |  |  |  |  |  |  |
| 2422 | 1.8.7.2 | Envelope/Submission Webinar |  | 1d | 2024-08-05 A | 2024-08-05 A | 2421FF | 100% |  | 2024-08-05 | 2024-08-05 | 1d |  |  |  |  |  | SRO Migration | SRO Migration,PP | Migration | 5.28 | Simon chidwick | Complete | COMPLETE |  |  |  |  |  |  |
| 2423 | 1.8.7.3 | Guides Creation |  | 45d | 2025-01-28 | 2025-03-31 | 2396FS+2d |  |  | 2025-01-28 | 2025-03-31 | 45d |  |  | 672d | 9d |  | SRO Migration | SRO Migration,PP | Migration | 5.28 | Simon chidwick | Green | GREEN | 62.33 |  |  |  |  |  |
| 2424 | 1.8.7.4 | Support Channels |  | 45d | 2025-01-28 | 2025-03-31 | 2396FS+2d |  |  | 2025-01-28 | 2025-03-31 | 45d |  |  | 672d | 9d |  | SRO Migration | SRO Migration,PP | Migration | 5.28 | Simon chidwick | Green | GREEN | 62.33 |  |  |  |  |  |
| 2425 | 1.8.8 | **Migration Artefact Development and Publication** |  | 772d | 2022-10-31 A | 2025-10-14 |  | 88% | 89.25d | 2022-10-31 | 2025-09-03 | 635d | 2022-10-31 | 2025-04-04 | 572d |  | -0 | N/A | N/A | Migration | 5.0 | N/A |  |  |  | Migration |  |  |  |  |
| 2426 | 1.8.8.1 | **Migration Approach** |  | 28d | 2022-10-31 A | 2022-12-07 A |  | 100% |  | 2022-10-31 | 2022-12-07 | 28d | 2022-10-31 | 2022-12-07 |  |  |  | N/A | N/A | Migration | 5.0 | N/A |  |  |  | Migration |  |  |  |  |
| 2427 | 1.8.8.1.1 | Option analysis (via MWG and PPIR) and recommendation |  | 23d | 2022-10-31 A | 2022-11-30 A |  | 100% |  | 2022-10-31 | 2022-11-30 | 23d | 2022-10-31 | 2022-11-30 |  |  |  | PP | SI Migration | Migration | 5.0 | John Wiggins,Matthew Breen | Complete | COMPLETE |  | Migration |  |  |  |  |
| 2428 | 1.8.8.1.2 | Migration Approach approved | milestone | 0d | 2022-12-07 A | 2022-12-07 A | 2427FS+5d | 100% |  | 2022-12-07 | 2022-12-07 | 0d | 2022-12-07 | 2022-12-07 |  |  |  | SI Migration | PP,IPA | Migration | 5.0 | John Wiggins,Matthew Breen | Complete | COMPLETE |  | Migration | MHHS-DEL770 | T3-MI-0010 | PSG | T3 |
| 2429 | 1.8.8.2 | **Migration Design** |  | 100d | 2022-11-14 A | 2023-03-31 A |  | 100% |  | 2022-11-14 | 2023-03-31 | 100d | 2022-11-14 | 2023-03-31 |  |  |  | N/A | N/A | Migration | 5.0 | N/A |  |  |  | Migration |  |  |  |  |
| 2430 | 1.8.8.2.1 | Review and update existing design artefacts and socialise with participants ahead of MDSG |  | 10d | 2022-11-14 A | 2022-11-25 A |  | 100% |  | 2022-11-14 | 2022-11-25 | 10d | 2022-11-14 | 2022-11-25 |  |  |  | SI Migration | SRO Design,CPT | Migration | 5.0 | John Wiggins,Matthew Breen | Complete | COMPLETE |  | Migration |  |  |  |  |
| 2431 | 1.8.8.2.2 | Develop design artefacts and supporting technical documents in line with MDSG |  | 53d | 2022-11-30 A | 2023-02-10 A | 2430FS+2d | 100% |  | 2022-11-30 | 2023-02-10 | 53d | 2022-11-30 | 2023-02-10 |  |  |  | SI Migration | PP,SRO Function,CPT | Migration | 5.0 | John Wiggins,Matthew Breen | Complete | COMPLETE |  | Migration |  |  |  |  |
| 2432 | 1.8.8.2.3 | Migration design artefacts issued for consultation | milestone | 0d | 2023-02-13 A | 2023-02-13 A | 2431FS+1d | 100% |  | 2023-02-13 | 2023-02-13 | 0d | 2023-02-13 | 2023-02-13 |  |  |  | SI Migration | PP,SRO Function,CPT | Migration | 5.0 | John Wiggins,Matthew Breen | Complete | COMPLETE |  | Migration |  | T3-MI-0011 | DAG | T3 |
| 2433 | 1.8.8.2.4 | Industry consultation |  | 5d | 2023-02-14 A | 2023-02-20 A | 2432SS | 100% |  | 2023-02-14 | 2023-02-20 | 5d | 2023-02-14 | 2023-02-20 |  |  |  | PP | SI Migration | Migration | 5.0 | John Wiggins,Matthew Breen | Complete | COMPLETE |  | Migration |  |  |  |  |
| 2434 | 1.8.8.2.5 | Review consultation feedback, address comments and update artefacts |  | 5d | 2023-02-21 A | 2023-02-27 A | 2433 | 100% |  | 2023-02-21 | 2023-02-27 | 5d | 2023-02-21 | 2023-02-27 |  |  |  | SI Migration | PP | Migration | 5.0 | John Wiggins,Matthew Breen | Complete | COMPLETE |  | Migration |  |  |  |  |
| 2435 | 1.8.8.2.6 | Internal artefact review and comms preparation |  | 3d | 2023-02-28 A | 2023-03-02 A | 2434 | 100% |  | 2023-02-28 | 2023-03-02 | 3d | 2023-02-28 | 2023-03-02 |  |  |  | SI Migration | SRO Function | Migration | 5.0 | John Wiggins,Matthew Breen | Complete | COMPLETE |  | Migration |  |  |  |  |
| 2436 | 1.8.8.2.7 | Updated Migration Design artefacts issued to PPs for assurance review | milestone | 0d | 2023-03-03 A | 2023-03-03 A | 2435FS+1d | 100% |  | 2023-03-03 | 2023-03-03 | 0d | 2023-03-03 | 2023-03-03 |  |  |  | SI Migration | PP | Migration | 5.0 | John Wiggins,Matthew Breen | Complete | COMPLETE |  | Migration |  | T3-MI-0013 | DAG | T3 |
| 2437 | 1.8.8.2.8 | Final Migration Design artefacts walkthrough with PPs | milestone | 0d | 2023-03-22 A | 2023-03-22 A | 2436FS+13d | 100% |  | 2023-03-22 | 2023-03-22 | 0d | 2023-03-22 | 2023-03-22 |  |  |  | SI Migration | PP | Migration | 5.0 | John Wiggins,Matthew Breen | Complete | COMPLETE |  | Migration |  |  |  |  |
| 2438 | 1.8.8.2.9 | Migration Design approved | milestone | 0d | 2023-03-31 A | 2023-03-31 A | 2437FS+7d | 100% |  | 2023-03-31 | 2023-03-31 | 0d | 2023-03-31 | 2023-03-31 |  |  |  | SI Migration | PP,SRO Function,CPT | Migration | 5.0 | John Wiggins,Matthew Breen | Complete | COMPLETE |  | Migration |  | T2-MI-0050 | DAG | T2 |

| ID | WBS | Task | Type | Duration | Start | Finish | Predecessors | Complete | Baseline start | Baseline finish | Baseline duration | Baseline 1 start | Baseline 1 finish | Baseline cost | Responsible | Involved | Text9 | Update Version | MHHS Resource Name | MHHS Programme Phase | Sched Status | RAG | Milestone ID | Text29 | Tier | Guidance |
| --- | --- | --- | --- | --- | --- | --- | --- | --- | --- | --- | --- | --- | --- | --- | --- | --- | --- | --- | --- | --- | --- | --- | --- | --- | --- | --- |
| 2439 | 1.8.8.3 | **Transition Design** |  | 186d | 2023-03-01 A | 2023-11-15 A |  | 100% | 2023-03-01 | 2023-11-15 | 186d | 2023-03-01 | 2023-08-03 | -0 | N/A | N/A | Migration | 5.0 | N/A | Migration |  |  |  |  |  |  |
| 2440 | 1.8.8.3.1 | **Tranche 1** |  | 56d | 2023-03-01 A | 2023-05-17 A |  | 100% | 2023-03-01 | 2023-05-17 | 56d | 2023-03-01 | 2023-05-17 |  | N/A | N/A | Migration | 5.0 | N/A | Migration |  |  |  |  |  |  |
| 2441 | 1.8.8.3.1.1 | Develop design artefacts and supporting technical details with participants |  | 50d | 2023-03-01 A | 2023-05-09 A |  | 100% | 2023-03-01 | 2023-05-09 | 50d | 2023-03-01 | 2023-05-09 |  | SI Design | PP | Migration | 5.0 | Andrew Margan | Migration | Complete | COMPLETE |  |  |  |  |
| 2442 | 1.8.8.3.1.2 | Issue Material for DAG approval |  | 1d | 2023-05-10 A | 2023-05-10 A | 2441 | 100% | 2023-05-10 | 2023-05-10 | 1d | 2023-05-10 | 2023-05-10 |  | PP | SI Design | Migration | 5.0 | Andrew Margan | Migration | Complete | COMPLETE |  |  |  |  |
| 2443 | 1.8.8.3.1.3 | Tranche 1 Transition Design approved | milestone | 0d | 2023-05-17 A | 2023-05-17 A | 2442FS+5d | 100% | 2023-05-17 | 2023-05-17 | 0d | 2023-05-17 | 2023-05-17 |  | SI Design | PP | Migration | 5.0 | Andrew Margan | Migration | Complete | COMPLETE | T2-DB-0150 | DAG | T2 |  |
| 2444 | 1.8.8.3.2 | **Tranche 2** |  | 130d | 2023-05-18 A | 2023-11-15 A |  | 100% | 2023-05-18 | 2023-11-15 | 130d | 2023-05-18 | 2023-08-03 | -0 | N/A | N/A | Migration | 5.0 | N/A | Migration |  |  |  |  |  |  |
| 2445 | 1.8.8.3.2.1 | Develop Initial design artefacts and supporting technical details |  | 76d | 2023-05-18 A | 2023-08-31 A | 2443 | 100% | 2023-05-18 | 2023-08-31 | 76d | 2023-05-18 | 2023-07-26 |  | SRO | PP, CPT, SRO Design | Migration | 5.5 | Andrew Margan | Migration | Complete | COMPLETE |  |  |  |  |
| 2446 | 1.8.8.3.2.2 | Communicate Initial Design Artefacts with Industry (MTDSG) |  | 1d | 2023-09-01 A | 2023-09-01 A | 2445 | 100% | 2023-09-01 | 2023-09-01 | 1d |  |  |  | SRO | PP, CPT, SRO Design | Migration | 5.5 | Andrew Margan | Migration | Complete | COMPLETE |  |  |  |  |
| 2447 | 1.8.8.3.2.3 | Host MTDSG |  | 1d | 2023-09-11 A | 2023-09-11 A | 2446FS+5d | 100% | 2023-09-11 | 2023-09-11 | 1d |  |  |  | SRO | PP, CPT, SRO Design | Migration | 5.5 | Andrew Margan | Migration | Complete | COMPLETE |  |  |  |  |
| 2448 | 1.8.8.3.2.4 | Process MTDSG Feedback and Amend Design Artefacts |  | 4d | 2023-09-12 A | 2023-09-15 A | 2447 | 100% | 2023-09-12 | 2023-09-15 | 4d |  |  |  | SRO | PP, CPT, SRO Design | Migration | 5.5 | Andrew Margan | Migration | Complete | COMPLETE |  |  |  |  |
| 2449 | 1.8.8.3.2.5 | Communicate Amended Design Artefacts with Industry |  | 1d | 2023-09-15 A | 2023-09-15 A | 2448FF | 100% | 2023-09-15 | 2023-09-15 | 1d |  |  |  | SRO | PP, CPT, SRO Design | Migration | 5.5 | Andrew Margan | Migration | Complete | COMPLETE |  |  |  |  |
| 2450 | 1.8.8.3.2.6 | Host MTDSG |  | 1d | 2023-09-26 A | 2023-09-26 A | 2449FS+6d | 100% | 2023-09-26 | 2023-09-26 | 1d |  |  |  | SRO | PP, CPT, SRO Design | Migration | 5.5 | Andrew Margan | Migration | Complete | COMPLETE |  |  |  |  |
| 2451 | 1.8.8.3.2.7 | Make Final Amendments to Design Artefact |  | 5d | 2023-09-27 A | 2023-10-03 A | 2450 | 100% | 2023-09-27 | 2023-10-03 | 5d |  |  |  | SRO | PP, CPT, SRO Design | Migration | 5.5 | Andrew Margan | Migration | Complete | COMPLETE |  |  |  |  |
| 2452 | 1.8.8.3.2.8 | Request DAG Consultation |  | 1d | 2023-10-04 A | 2023-10-04 A | 2451 | 100% | 2023-10-04 | 2023-10-04 | 1d |  |  |  | SRO | PP, CPT, SRO Design | Migration | 5.5 | Andrew Margan | Migration | Complete | COMPLETE |  |  |  |  |
| 2453 | 1.8.8.3.2.9 | Consultation Period |  | 11d | 2023-10-04 A | 2023-10-18 A | 2452SS | 100% | 2023-10-04 | 2023-10-18 | 11d |  |  |  | SRO | PP, CPT, SRO Design | Migration | 5.5 | Andrew Margan | Migration | Complete | COMPLETE |  |  |  |  |
| 2454 | 1.8.8.3.2.10 | Action Consultation Comments |  | 5d | 2023-10-19 A | 2023-10-25 A | 2453 | 100% | 2023-10-19 | 2023-10-25 | 5d |  |  |  | SRO | PP, CPT, SRO Design | Migration | 5.5 | Andrew Margan | Migration | Complete | COMPLETE |  |  |  |  |
| 2455 | 1.8.8.3.2.11 | Post Consultation Industry Assurance |  | 5d | 2023-10-26 A | 2023-11-01 A | 2454 | 100% | 2023-10-26 | 2023-11-01 | 5d |  |  |  | SRO | PP, CPT, SRO Design | Migration | 5.5 | Andrew Margan | Migration | Complete | COMPLETE |  |  |  |  |
| 2456 | 1.8.8.3.2.12 | Request DAG Approval |  | 1d | 2023-11-01 A | 2023-11-01 A | 2455FF | 100% | 2023-11-01 | 2023-11-01 | 1d |  |  |  | SRO | PP, CPT, SRO Design | Migration | 5.5 | Andrew Margan | Migration | Complete | COMPLETE |  |  |  |  |
| 2457 | 1.8.8.3.2.13 | DAG Transition Design Approved |  | 1d | 2023-11-08 A | 2023-11-08 A | 2456FS+4d | 100% | 2023-11-08 | 2023-11-08 | 1d |  |  |  | SRO | PP, CPT, SRO Design | Migration | 5.5 | Andrew Margan | Migration | Complete | COMPLETE |  |  |  |  |
| 2458 | 1.8.8.3.2.14 | Update Transition Design Admin |  | 5d | 2023-11-09 A | 2023-11-15 A | 2457 | 100% | 2023-11-09 | 2023-11-15 | 5d |  |  |  | SRO | PP, CPT, SRO Design | Migration | 5.5 | Andrew Margan | Migration | Complete | COMPLETE |  |  |  |  |
| 2459 | 1.8.8.3.2.15 | Tranche 2 Transition Design Baselined | milestone | 0d | 2023-11-15 A | 2023-11-15 A | 2458 | 100% | 2023-11-15 | 2023-11-15 | 0d | 2023-08-03 | 2023-08-03 |  | SRO | PP, CPT, SRO Design | Migration | 5.12 | Andrew Margan | Migration | Complete | COMPLETE | T2-DB-0250 | DAG | T2 | 14/8 - Date aligns with DAG |
| 2460 | 1.8.8.4 | **Data Assessment Report** |  | 61d | 2022-12-06 A | 2023-02-28 A |  | 100% | 2022-12-06 | 2023-02-28 | 61d | 2022-12-06 | 2023-02-28 |  | N/A | N/A | Migration | 5.0 | N/A | Migration |  |  |  |  |  |  |
| 2461 | 1.8.8.4.1 | Develop document with MWG |  | 49d | 2022-12-06 A | 2023-02-10 A |  | 100% | 2022-12-06 | 2023-02-10 | 49d | 2022-12-06 | 2023-02-10 |  | SI Migration |  | Migration | 5.0 | John Wiggins,Matthew Breen | Migration | Complete | COMPLETE |  |  |  |  |
| 2462 | 1.8.8.4.2 | Artefact review (via TMAG) and updates |  | 25d | 2023-01-18 A | 2023-02-21 A | 2461FS-18d | 100% | 2023-01-18 | 2023-02-21 | 25d | 2023-01-18 | 2023-02-21 |  | PP | IPA,SI Migration | Migration | 5.0 | John Wiggins,Matthew Breen | Migration | Complete | COMPLETE |  |  |  |  |
| 2463 | 1.8.8.4.3 | Data Assessment Report approved | milestone | 0d | 2023-02-28 A | 2023-02-28 A | 2462FS+5d | 100% | 2023-02-28 | 2023-02-28 | 0d | 2023-02-28 | 2023-02-28 |  | SI Migration | PP,IPA | Migration | 5.0 | John Wiggins,Matthew Breen | Migration | Complete | COMPLETE | T3-MI-0012 | MCAG | T3 |  |

Notes:
- 2459: Action: 2/8/23 - needs to be replanned to 15//11/23. AM to raise CR as T2 milestone

| ID | WBS | Task | Type | Duration | Start | Finish | Predecessors | Complete | Remaining | Baseline start | Baseline finish | Baseline duration | Baseline 1 start | Baseline 1 finish | Total slack | Free slack | Constraint | Baseline cost | Responsible | Involved | Text9 | Update Version | MHHS Resource Name | MHHS Programme Phase | Sched Status | RAG | Milestone ID | Text29 | Tier | Task Status | Guidance |
| --- | --- | --- | --- | --- | --- | --- | --- | --- | --- | --- | --- | --- | --- | --- | --- | --- | --- | --- | --- | --- | --- | --- | --- | --- | --- | --- | --- | --- | --- | --- | --- |
| 2464 | 1.8.8.5 | **Migration, Cutover & Data Strategy (incl. Migration Entry Criteria)** |  | 102d | 2022-12-08 A | 2023-04-28 A |  | 100% |  | 2022-12-08 | 2023-04-28 | 102d | 2022-12-08 | 2023-04-28 |  |  |  |  | N/A | N/A | Migration | 5.0 | N/A | Migration |  |  |  |  |  |  |  |
| 2465 | 1.8.8.5.1 | Develop document with MWG |  | 67d | 2022-12-08 A | 2023-03-10 A | 2428 | 100% |  | 2022-12-08 | 2023-03-10 | 67d | 2022-12-08 | 2023-03-10 |  |  |  |  | SI Migration | PP | Migration | 5.0 | John Wiggins,Matthew Breen | Migration | Complete | COMPLETE |  |  |  |  |  |
| 2466 | 1.8.8.5.2 | Artefact review (via TMAG) and updates |  | 28d | 2023-03-15 A | 2023-04-21 A | 2465FS+2d | 100% |  | 2023-03-15 | 2023-04-21 | 28d | 2023-03-15 | 2023-04-21 |  |  |  |  | PP | SI Migration | Migration | 5.0 | John Wiggins,Matthew Breen | Migration | Complete | COMPLETE |  |  |  |  |  |
| 2467 | 1.8.8.5.3 | Migration, Cutover & Data Strategy approved | milestone | 0d | 2023-04-28 A | 2023-04-28 A | 2466FF+5d | 100% |  | 2023-04-28 | 2023-04-28 | 0d | 2023-04-28 | 2023-04-28 |  |  |  |  | SI Migration | PP | Migration | 5.0 | John Wiggins,Matthew Breen | Migration | Complete | COMPLETE | T3-MI-0014 | MCAG | T3 |  |  |
| 2468 | 1.8.8.6 | **Data Cleanse Plan** |  | 684d | 2023-03-02 A | 2025-10-14 |  | 80% | 136.57d | 2023-03-02 | 2025-09-03 | 547d | 2023-03-02 | 2025-04-04 | 572d |  |  | -0 | N/A | N/A | Migration | 5.0 | N/A | Migration |  |  |  |  |  |  |  |
| 2469 | 1.8.8.6.1 | Develop document with MWG |  | 50d | 2023-03-02 A | 2023-05-10 A |  | 100% |  | 2023-03-02 | 2023-05-10 | 50d | 2023-03-02 | 2023-05-10 |  |  |  |  | SI Migration | PP | Migration | 5.0 | John Wiggins,Matthew Breen | Migration | Complete | COMPLETE |  |  |  |  |  |
| 2470 | 1.8.8.6.2 | Artefact review (via TMAG) and updates |  | 20d | 2023-05-11 A | 2023-06-07 A | 2469 | 100% |  | 2023-05-11 | 2023-06-07 | 20d | 2023-05-11 | 2023-06-07 |  |  |  |  | PP | SI Migration,IPA | Migration | 5.0 | John Wiggins,Matthew Breen | Migration | Complete | COMPLETE |  |  |  |  |  |
| 2471 | 1.8.8.6.3 | Data Cleanse Plan approved | milestone | 0d | 2023-07-19 A | 2023-07-19 A | 2470FS+30d | 100% |  | 2023-07-19 | 2023-07-19 | 0d | 2023-06-14 | 2023-06-14 |  |  |  |  | SI Migration | PP | Migration | 5.0 | John Wiggins,Matthew Breen | Migration | Complete | COMPLETE | T3-MI-0020 | MCAG | T3 |  |  |
| 2472 | 1.8.8.6.4 | Monitor Programme Participant adherence to Data Cleanse Plan |  | 467d | 2023-06-15 A | 2025-03-28 | 2471 | 76% | 114d | 2023-06-15 | 2025-03-28 | 467d | 2023-06-15 | 2025-03-28 | 714d |  |  |  | SI Migration | PP | Migration | 5.0 | Matthew Breen | Migration | Green | GREEN |  |  |  |  |  |
| 2473 | 1.8.8.6.5 | **MTDs** |  | 119d | 2024-08-16 A | 2025-01-30 |  | 95% | 5.95d | 2024-08-16 | 2025-01-31 | 91d |  |  | 755d |  |  | -0 | N/A | N/A | Transition | 5.4 | N/A | Migration |  |  |  |  |  |  |  |
| 2474 | 1.8.8.6.5.1 | **ESME ID** |  | 90d | 2024-08-16 A | 2024-12-20 |  | 94% | 5.29d | 2024-08-16 | 2024-12-20 | 90d |  |  | 784d |  |  | -0 | N/A | N/A | Transition | 5.4 | N/A | Migration |  |  |  |  |  |  |  |
| 2475 | 1.8.8.6.5.1.1 | DCC to extract ESME ID and share with LDSO | milestone | 0d | 2024-08-16 A | 2024-08-16 A | 2471FS+282d | 100% |  | 2024-08-16 | 2024-08-16 | 0d |  |  |  |  |  |  | DCC/SI |  | Transition | 5.5 | Matthew Breen | Migration | Complete | COMPLETE | T3-MI-0024 | MCAG (Transition) | T3 |  |  |
| 2476 | 1.8.8.6.5.1.2 | LDSO ‘full refresh’ between their Registration Service and the EES (ESME ID) |  | 16d | 2024-10-21 A | 2024-11-11 A | 2475FS+45d | 100% |  | 2024-10-21 | 2024-11-11 | 0d |  |  |  |  |  |  | LDSO/EES |  | Transition | 5.5 | Matthew Breen | Migration | Complete | COMPLETE | T3-MI-0025 | MCAG (Transition) | T3 |  |  |
| 2477 | 1.8.8.6.5.1.3 | Suppliers complete investigation of exceptions and resolution of exceptions |  | 1d | 2024-12-20 | 2024-12-20 | 2476FS+28d |  |  | 2024-12-20 | 2024-12-20 | 1d |  |  | 784d | 0d |  |  | Supplier |  | Transition | 5.4 | Matthew Breen | Migration | Green | GREEN |  |  |  | 23.33 |  |
| 2478 | 1.8.8.6.5.1.4 | ESME ID Complete | milestone | 0d | 2024-12-20 | 2024-12-20 | 2477 |  |  | 2024-12-20 | 2024-12-20 | 0d |  |  | 784d |  |  |  |  |  | Transition | 5.4 | Matthew Breen | Migration | Green | GREEN |  |  |  | 23.71 |  |
| 2479 | 1.8.8.6.5.2 | **Meter Location and Number of Displayed Register Digits** |  | 100d | 2024-09-13 A | 2025-01-30 |  | 96% | 4.35d | 2024-09-13 | 2025-01-31 | 91d |  |  | 755d |  |  |  | N/A | N/A | Transition | 5.4 | N/A | Migration |  |  |  |  |  |  |  |
| 2480 | 1.8.8.6.5.2.1 | MEM to extract data and share with LDSO |  | 6d | 2024-09-13 A | 2024-09-20 A | 2471FS+301d | 100% |  | 2024-09-13 | 2024-09-20 | 1d |  |  |  |  |  |  | MEM/SI |  | Transition | 5.4 | Matthew Breen | Migration | Complete | COMPLETE |  |  |  |  |  |
| 2481 | 1.8.8.6.5.2.2 | LDSO ‘full refresh’ between their Registration Service and the EES (Meter Location and Number of Displayed Register Digits) |  | 16d | 2024-10-21 A | 2024-11-15 A | 2480FS+25d | 100% |  | 2024-10-28 | 2024-11-18 | 0d |  |  |  |  |  |  | LDSO /EES |  | Transition | 5.5 | Matthew Breen | Migration | Complete | COMPLETE | T3-MI-0026 | MCAG (Transition) | T3 |  |  |
| 2482 | 1.8.8.6.5.2.3 | Suppliers complete investigation of exceptions and resolution of exceptions |  | 1d | 2025-01-30 | 2025-01-30 | 2481FS+53d |  |  | 2025-01-31 | 2025-01-31 | 1d |  |  | 755d | 0d |  |  | Supplier |  | Transition | 5.4 | Matthew Breen | Migration | Green | GREEN |  |  |  | 64.33 |  |
| 2483 | 1.8.8.6.5.2.4 | Meter Location and Number of Displayed Register Digits Complete | milestone | 0d | 2025-01-30 | 2025-01-30 | 2482 |  |  | 2025-01-31 | 2025-01-31 | 0d |  |  | 755d |  |  |  |  |  | Transition | 5.4 | Matthew Breen | Migration | Green | GREEN |  |  |  | 64.71 |  |
| 2484 | 1.8.8.6.6 | **Registration Data** |  | 288d | 2024-09-06 A | 2025-10-14 |  | 81% | 54.86d | 2024-09-06 | 2025-09-03 | 147d |  |  | 572d |  |  |  | N/A | N/A | Transition | 5.4 | N/A | Migration |  |  |  |  |  |  |  |
| 2485 | 1.8.8.6.6.1 | **Connection Type** |  | 47d | 2024-09-06 A | 2024-11-11 A |  | 100% |  | 2024-09-06 | 2024-11-11 | 16d |  |  |  |  |  |  | N/A | N/A | Transition | 5.4 | N/A | Migration |  |  |  |  |  |  |  |
| 2486 | 1.8.8.6.6.1.1 | Automated Population of Connection Type for Measurement Classes ‘B’, ‘D’, ‘F’ & ‘G’ | milestone | 0d | 2024-10-04 A | 2024-10-04 A | 2471FS+317d | 100% |  | 2024-10-04 | 2024-10-04 | 0d |  |  |  |  | start no earlier than 2024-09-13 |  | LDSO |  | Transition | 5.5 | Matthew Breen | Migration | Complete | COMPLETE | T3-MI-0027 | MCAG (Transition) | T3 |  |  |
| 2487 | 1.8.8.6.6.1.2 | BAU Population of Connection Type for Site Specific LLFCs within Measurement Classes ‘C’ & ‘E’ | milestone | 0d | 2024-10-04 A | 2024-10-04 A | 2471FS+317d | 100% |  | 2024-10-04 | 2024-10-04 | 0d |  |  |  |  |  |  | LDSO |  | Transition | 5.5 | Matthew Breen | Migration | Complete | COMPLETE | T3-MI-0028 | MCAG (Transition) | T3 |  |  |
| 2488 | 1.8.8.6.6.1.3 | Automated Population of Connection Type for Smart Meters within Measurement Class ‘A’ | milestone | 0d | 2024-10-04 A | 2024-10-04 A | 2471FS+317d | 100% |  | 2024-10-04 | 2024-10-04 | 0d |  |  |  |  |  |  | LDSO |  | Transition | 5.5 | Matthew Breen | Migration | Complete | COMPLETE | T3-MI-0029 | MCAG (Transition) | T3 |  |  |
| 2489 | 1.8.8.6.6.1.4 | Population of Connection Type for Traditional and Advanced Meters within Measurement Class ‘A’ |  | 1d | 2024-09-06 A | 2024-09-06 A | 2471FS+296d | 100% |  | 2024-09-06 | 2024-09-06 | 1d |  |  |  |  |  |  | Suppliers |  | Transition | 5.4 | Matthew Breen | Migration | Complete | COMPLETE |  |  |  |  |  |
| 2490 | 1.8.8.6.6.1.5 | Automated Population of Null Connection Type | milestone | 0d | 2024-10-04 A | 2024-10-04 A | 2471FS+317d | 100% |  | 2024-10-04 | 2024-10-04 | 0d |  |  |  |  |  |  | LDSO |  | Transition | 5.5 | Matthew Breen | Migration | Complete | COMPLETE | T3-MI-0030 | MCAG (Transition) | T3 |  |  |
| 2491 | 1.8.8.6.6.1.6 | Full MPAN refresh to ESS |  | 16d | 2024-10-21 A | 2024-11-11 A | 2471FS+327d | 100% |  | 2024-10-21 | 2024-11-11 | 1d |  |  |  |  |  |  | LDSO/EES |  | Transition | 5.4 | Matthew Breen | Migration | Complete | COMPLETE |  |  |  |  | Actually takes place on 29/9/24 which is a Sunday |
| 2492 | 1.8.8.6.6.1.7 | Connection Type Complete | milestone | 0d | 2024-11-11 A | 2024-11-11 A | 2486, 2487, 2488, 2489, 2490, 2491 | 100% |  | 2024-11-11 | 2024-11-11 | 0d |  |  |  |  |  |  |  |  | Transition | 5.4 | Matthew Breen | Migration | Complete | COMPLETE |  |  |  |  |  |

Notes:
- 2478: Action: 2/8/24: is date right as different to baseline? Why was it 23rd?

| ID | WBS | Task | Type | Duration | Start | Finish | Predecessors | Complete | Remaining | Baseline start | Baseline finish | Baseline duration | Baseline 1 start | Baseline 1 finish | Total slack | Free slack | Constraint | Baseline cost | Responsible | Involved | Text9 | Update Version | MHHS Resource Name | MHHS Programme Phase | Guidance | Task Status | Sched Status | RAG | Milestone ID | Text29 | Tier |
| --- | --- | --- | --- | --- | --- | --- | --- | --- | --- | --- | --- | --- | --- | --- | --- | --- | --- | --- | --- | --- | --- | --- | --- | --- | --- | --- | --- | --- | --- | --- | --- |
| 2493 | 1.8.8.6.6.2 | **Domestic Premises Indicator** |  | 19d | 2025-09-18 | 2025-10-14 |  |  |  | 2025-08-08 | 2025-09-03 | 17d |  |  | 572d |  |  |  | N/A | N/A | Transition | 5.4 | N/A | Migration |  |  |  |  |  |  |  |
| 2494 | 1.8.8.6.6.2.1 | The DCC to extract Domestic Premises Indicator from the CSS and provide a file to each LDSO and EES. |  | 2d | 2025-09-18 | 2025-09-19 | 1712FS-4d |  |  | 2025-09-19 | 2025-09-22 | 1d |  |  | 572d | 0d | start no earlier than 2025-08-08 |  | DCC |  | Transition | 5.4 | Matthew Breen | Migration | 27/7 - needs to end on date of M10 7/3/25 | 295.33 | Green | GREEN |  |  |  |
| 2495 | 1.8.8.6.6.2.2 | Each LDSO notifies the DCC of any exceptions |  | 1d | 2025-09-22 | 2025-09-22 | 2494 |  |  | 2025-09-23 | 2025-09-23 | 1d |  |  | 572d | 0d |  |  | LDSO |  | Transition | 5.4 | Matthew Breen | Migration | 27/7 - needs to end on date of M10 7/3/25 | 299.33 | Green | GREEN |  |  |  |
| 2496 | 1.8.8.6.6.2.3 | Each LDSO and DCC completes investigation and resolution of exceptions |  | 1d | 2025-10-14 | 2025-10-14 | 2494FS+15d, 2495FS+15d |  |  | 2025-10-15 | 2025-10-15 | 1d |  |  | 572d | 0d |  |  | LDSO / DCC |  | Transition | 5.4 | Matthew Breen | Migration | 27/7 Needs to take place approx. 1 month after M10 | 321.33 | Green | GREEN |  |  |  |
| 2497 | 1.8.8.6.6.2.4 | Domestic Premises Indicator Complete | milestone | 0d | 2025-10-14 | 2025-10-14 | 2496 |  |  | 2025-10-15 | 2025-10-15 | 0d |  |  | 572d |  |  |  |  |  | Transition | 5.4 | Matthew Breen | Migration |  | 321.71 | Green | GREEN |  |  |  |
| 2498 | 1.8.8.6.7 | **Export / Import MPANs** |  | 151d | 2024-03-22 A | 2024-10-18 A |  | 100% |  | 2024-03-22 | 2024-10-18 | 151d |  |  |  |  |  |  | N/A | N/A | Transition | 5.4 | N/A | Migration |  |  |  |  |  |  |  |
| 2499 | 1.8.8.6.7.1 | **Linking of Export / Import MPANS** |  | 151d | 2024-03-22 A | 2024-10-18 A |  | 100% |  | 2024-03-22 | 2024-10-18 | 151d |  |  |  |  |  |  | N/A | N/A | Transition | 5.4 | N/A | Migration |  |  |  |  |  |  |  |
| 2500 | 1.8.8.6.7.1.1 | LDSO utilises BAU processing (DB05s) to populate each import/export association |  | 1d | 2024-03-22 A | 2024-03-22 A | 2471FS+176d | 100% |  | 2024-03-22 | 2024-03-22 | 1d |  |  |  |  |  |  | LDSO |  | Transition | 5.4 | Matthew Breen | Migration |  |  | Complete | COMPLETE |  |  |  |
| 2501 | 1.8.8.6.7.1.2 | Each LDSO notifies the Registered Supplier of any exceptions |  | 1d | 2024-04-19 A | 2024-04-19 A | 2500FS+19d | 100% |  | 2024-04-19 | 2024-04-19 | 1d |  |  |  |  |  |  | LDSO |  | Transition | 5.4 | Matthew Breen | Migration |  |  | Complete | COMPLETE |  |  |  |
| 2502 | 1.8.8.6.7.1.3 | Each Supplier completes investigation and resolution of exceptions |  | 1d | 2024-08-23 A | 2024-08-23 A | 2501FS+89d | 100% |  | 2024-08-23 | 2024-08-23 | 1d |  |  |  |  |  |  | Supplier |  | Transition | 5.4 | Matthew Breen | Migration |  |  | Complete | COMPLETE |  |  |  |
| 2503 | 1.8.8.6.7.1.4 | Each LDSO has linked al relevant import/export MPANS | milestone | 0d | 2024-10-18 A | 2024-10-18 A | 2502FS+40d | 100% |  | 2024-10-18 | 2024-10-18 | 0d |  |  |  |  |  |  | LDSO |  | Transition | 5.5 | Matthew Breen | Migration |  |  | Complete | COMPLETE | T3-MI-0031 | MCAG (Transition) | T3 |
| 2504 | 1.8.8.6.7.1.5 | Linking of Export / Import MPANS Complete | milestone | 0d | 2024-10-18 A | 2024-10-18 A | 2503 | 100% |  | 2024-10-18 | 2024-10-18 | 0d |  |  |  |  |  |  |  |  | Transition | 5.4 | Matthew Breen | Migration |  |  | Complete | COMPLETE |  |  |  |
| 2505 | 1.8.8.6.8 | Pre-migration data cleanse complete | milestone | 0d | 2025-08-13 | 2025-08-13 |  |  |  | 2025-08-13 | 2025-08-13 | 0d | 2025-04-04 | 2025-04-04 | 617d |  | start no earlier than 2025-08-13 |  | SI Migration | PP | Transition | 5.0 | Matthew Breen | Migration |  | 259.33 | Green | GREEN | T2-MI-0450 | MCAG (Transition) | T2 |
| 2506 | 1.8.9 | **Migration Period Planning** |  | 367d | 2023-07-03 A | 2024-11-26 |  | 83% | 61.71d | 2023-07-03 | 2024-11-26 | 851d | 2023-07-03 | 2026-10-05 | 678d |  |  | -0 | N/A | N/A | Transition | 5.0 | N/A | Migration |  | M10 |  |  |  |  |  |
| 2507 | 1.8.9.1 | **Migration Implementation Plan (incl. Migration Exit Criteria)** |  | 367d | 2023-07-03 A | 2024-11-26 |  | 83% | 61.71d | 2023-07-03 | 2024-11-26 | 851d | 2023-07-03 | 2026-10-05 | 678d |  |  | -0 | N/A | N/A | Transition | 5.0 | N/A | Migration |  |  |  |  |  |  |  |
| 2508 | 1.8.9.1.1 | **Migration Threshold Volumes** |  | 101d | 2023-07-03 A | 2023-11-20 A |  | 100% |  | 2023-07-03 | 2023-11-20 | 98d | 2023-07-03 | 2023-08-31 |  |  |  | -0 | N/A | N/A | Transition | 5.0 | N/A | Migration |  |  |  |  |  |  |  |
| 2509 | 1.8.9.1.1.1 | Threshold volumes reviewed by MWG |  | 54d | 2023-07-03 A | 2023-09-14 A |  | 100% |  | 2023-07-03 | 2023-09-14 | 54d | 2023-07-03 | 2023-07-28 |  |  |  |  | SI Migration | PP | Transition | 5.6 | John Wiggins,Matthew Breen | Migration |  |  | Complete | COMPLETE |  |  |  |
| 2510 | 1.8.9.1.1.2 | Artefact review (via TMAG) and updates |  | 47d | 2023-09-15 A | 2023-11-20 A | 2509 | 100% |  | 2023-09-15 | 2023-11-20 | 44d | 2023-07-31 | 2023-08-31 |  |  |  |  | PP | SI Migration | Transition | 5.9 | John Wiggins,Matthew Breen | Migration |  |  | Complete | COMPLETE |  |  |  |
| 2511 | 1.8.9.1.1.3 | Threshold volumes approved at TMAG | milestone | 0d | 2023-11-20 A | 2023-11-20 A | 2510 | 100% |  | 2023-11-20 | 2023-11-20 | 0d | 2023-08-31 | 2023-08-31 |  |  |  |  | SI Migration | PP | Transition | 5.12 | John Wiggins,Matthew Breen | Migration |  |  | Complete | COMPLETE | T3-MI-0021 | SITAG | T3 |
| 2512 | 1.8.9.1.2 | **Define acceptance criteria for M15** |  | 78d | 2023-09-04 A | 2023-12-20 A |  | 100% |  | 2023-09-04 | 2023-12-20 | 78d | 2023-09-04 | 2023-11-30 |  |  |  | -0 | N/A | N/A | Transition | 5.0 | N/A | Migration |  |  |  |  |  |  |  |
| 2513 | 1.8.9.1.2.1 | Review acceptance criteria and reporting requirements with MWG |  | 49d | 2023-09-04 A | 2023-11-09 A |  | 100% |  | 2023-09-04 | 2023-11-09 | 40d | 2023-09-04 | 2023-10-27 |  |  | start no earlier than 2023-09-04 |  | SI Migration |  | Transition | 5.0 | John Wiggins,Matthew Breen | Migration |  |  | Complete | COMPLETE |  |  |  |
| 2514 | 1.8.9.1.2.2 | Artefact review (via TMAG) and updates |  | 29d | 2023-11-10 A | 2023-12-20 A | 2513 | 100% |  | 2023-11-10 | 2023-12-20 | 29d | 2023-10-30 | 2023-11-30 |  |  | start no earlier than 2023-10-30 |  | PP | SI Migration | Transition | 5.0 | John Wiggins,Matthew Breen | Migration |  |  | Complete | COMPLETE |  |  |  |
| 2515 | 1.8.9.1.2.3 | Acceptance criteria for M15 agreed at TMAG | milestone | 0d | 2023-12-20 A | 2023-12-20 A | 2514 | 100% |  | 2023-12-20 | 2023-12-20 | 0d | 2023-11-30 | 2023-11-30 |  |  | finish no earlier than 2023-11-30 |  | SI Migration |  | Transition | 5.14 | John Wiggins,Matthew Breen | Migration |  |  | Complete | COMPLETE | T3-MI-0022 | SITAG | T3 |
| 2516 | 1.8.9.1.3 | **M10/M11 cut-over plan** |  | 119d | 2023-12-21 A | 2024-06-04 A |  | 100% |  | 2023-12-21 | 2024-06-04 | 119d | 2024-01-01 | 2024-05-31 |  |  |  | -0 | N/A | N/A | Transition | 5.16 | N/A | Migration |  |  |  |  |  |  |  |
| 2517 | 1.8.9.1.3.1 | Draft Document |  | 84d | 2023-12-21 A | 2024-04-16 A | 2515 | 100% |  | 2023-12-21 | 2024-04-16 | 84d |  |  |  |  |  |  | SI Transition | SI Transition,PP,SRO | Transition | 5.16 | Matthew Breen | Migration |  |  | Complete | COMPLETE |  |  |  |
| 2518 | 1.8.9.1.3.2 | Share Document with SRO |  | 1d | 2024-04-17 A | 2024-04-17 A | 2517 | 100% |  | 2024-04-17 | 2024-04-17 | 1d |  |  |  |  |  |  | SI Transition | SI Transition,PP,SRO | Transition | 5.16 | Matthew Breen | Migration |  |  | Complete | COMPLETE |  |  |  |
| 2519 | 1.8.9.1.3.3 | Industry Consultation |  | 11d | 2024-04-23 A | 2024-05-07 A | 2518FS+3d | 100% |  | 2024-04-23 | 2024-05-07 | 11d |  |  |  |  |  |  | SI Transition | SI Transition,PP,SRO | Transition | 5.16 | Matthew Breen | Migration |  |  | Complete | COMPLETE |  |  |  |
| 2520 | 1.8.9.1.3.4 | Assurance Meeting |  | 1d | 2024-05-21 A | 2024-05-21 A | 2519FS+9d | 100% |  | 2024-05-21 | 2024-05-21 | 1d |  |  |  |  |  |  | SI Transition | SI Transition,PP,SRO | Transition | 5.16 | Matthew Breen | Migration |  |  | Complete | COMPLETE |  |  |  |
| 2521 | 1.8.9.1.3.5 | MCAG Approval of M10/M11 Cut-over Plan | milestone | 0d | 2024-06-04 A | 2024-06-04 A | 2520FS+10d | 100% |  | 2024-06-04 | 2024-06-04 | 0d | 2024-05-31 | 2024-05-31 |  |  |  |  | SI Transition | SI Transition,PP,SRO | Transition | 5.26 | Matthew Breen | Migration |  |  | Complete | COMPLETE | T3-MI-0023 | MCAG | T3 |

| ID | WBS | Task | Type | Duration | Start | Finish | Predecessors | Complete | Remaining | Baseline start | Baseline finish | Baseline duration | Baseline 1 start | Baseline 1 finish | Total slack | Free slack | Constraint | Baseline cost | Responsible | Involved | Text9 | Update Version | MHHS Resource Name | MHHS Programme Phase | Sched Status | RAG | Task Status | Milestone ID | Text29 | Tier | Action |
| --- | --- | --- | --- | --- | --- | --- | --- | --- | --- | --- | --- | --- | --- | --- | --- | --- | --- | --- | --- | --- | --- | --- | --- | --- | --- | --- | --- | --- | --- | --- | --- |
| 2522 | 1.8.9.1.4 | **M16 Methodology** |  | 85d | 2024-07-31 A | 2024-11-26 |  | 10% | 76.9d | 2024-07-31 | 2024-11-26 | 85d | 2023-10-02 | 2024-04-26 | 678d |  |  | -0 | N/A | N/A | Transition | 5.0 | N/A | Migration |  |  |  |  |  |  |  |
| 2523 | 1.8.9.1.4.1 | Draft Document |  | 50d | 2024-07-31 A | 2024-10-08 |  | 12% | 44d | 2024-07-31 | 2024-10-08 | 50d | 2023-10-02 | 2023-12-29 | 678d | 0d |  |  | SI Transition | SI Transition,PP,SRO | Transition | 5.26 | Matthew Breen | Migration | Overdue | RED |  |  |  |  |  |
| 2524 | 1.8.9.1.4.2 | Share Document with SRO |  | 1d | 2024-10-09 | 2024-10-09 | 2523 |  |  | 2024-10-09 | 2024-10-09 | 1d | 2024-01-01 | 2024-01-26 | 678d | 0d |  |  | SI Transition | SI Transition,PP,SRO | Transition | 5.26 | Matthew Breen | Migration | Overdue Start | RED | -48.67 |  |  |  |  |
| 2525 | 1.8.9.1.4.3 | Industry Consultation |  | 11d | 2024-10-15 | 2024-10-29 | 2524FS+3d |  |  | 2024-10-15 | 2024-10-29 | 11d | 2024-01-29 | 2024-03-29 | 678d | 0d |  |  | SI Transition | SI Transition,PP,SRO | Transition | 5.26 | Matthew Breen | Migration | Overdue Start | RED | -42.67 |  |  |  |  |
| 2526 | 1.8.9.1.4.4 | Assurance Meeting |  | 1d | 2024-11-12 | 2024-11-12 | 2525FS+9d |  |  | 2024-11-12 | 2024-11-12 | 1d | 2024-04-01 | 2024-04-26 | 678d | 0d |  |  | SI Transition | SI Transition,PP,SRO | Transition | 5.26 | Matthew Breen | Migration | Green | RED | -14.67 |  |  |  |  |
| 2527 | 1.8.9.1.4.5 | M16 methodology approved | milestone | 0d | 2024-11-26 | 2024-11-26 | 2526FS+10d |  |  | 2024-11-26 | 2024-11-26 | 0d | 2024-04-26 | 2024-04-26 | 678d |  |  |  | SI Transition | SI Transition,PP,SRO | Transition | 5.26 | Matthew Breen | Migration | Green | RED | -0.29 | T3-MI-0500 | MCAG (Transition) | T2 |  |
| 2528 | 1.8.10 | **Preparation for Cutover to Live** |  | 340d | 2024-06-28 A | 2025-10-16 |  |  | 340d | 2024-06-28 | 2025-10-22 | 201d | 2025-02-07 | 2025-04-04 | 570d |  |  | -0 | N/A | N/A | Transition | 6.11 | N/A | Migration |  |  |  |  |  |  |  |
| 2529 | 1.8.10.1 | **Central Systems Prepare for Cutover to Live** |  | 326d | 2024-06-28 A | 2025-09-26 |  |  | 326d | 2024-06-28 | 2025-09-26 | 186d | 2025-02-07 | 2025-03-07 | 584d |  |  | -0 | N/A | N/A | Transition | 6.11 | N/A | Migration |  |  | M13 |  |  |  |  |
| 2530 | 1.8.10.1.1 | DCC (Functionality available June 2024) | milestone | 0d | 2024-06-28 A | 2024-06-28 A |  | 100% |  | 2024-06-28 | 2024-06-28 | 0d |  |  |  |  | start no earlier than 2024-06-28 |  | DCC |  | Transition | 6.11 | Matthew Breen |  | Complete | COMPLETE |  |  |  |  |  |
| 2531 | 1.8.10.1.2 | **Development of Comms Approach and Declaration Guidance** |  | 79d | 2025-04-28 | 2025-08-14 |  |  |  | 2025-03-03 | 2025-06-19 | 79d |  |  | 34d |  |  |  | N/A | N/A | Transition | 6.11 | N/A |  |  |  | 95.33 |  |  |  |  |
| 2532 | 1.8.10.1.2.1 | Draft Cutover Comms Approach |  | 59d | 2025-04-28 | 2025-07-17 |  |  |  | 2025-04-28 | 2025-07-17 | 59d |  |  | 34d | 0d | start no earlier than 2025-04-28 |  | SI Transition | SI Transition | Transition | 6.11 | Matthew Breen |  | Green | GREEN | 152.33 |  |  |  |  |
| 2533 | 1.8.10.1.2.2 | Draft Cutover Comms Approach shared | milestone | 0d | 2025-07-17 | 2025-07-17 | 2532 |  |  | 2025-07-17 | 2025-07-17 | 0d |  |  | 34d | 0d |  |  | SI Transition | SI Transition | Transition | 6.11 | Matthew Breen |  | Green | GREEN | 232.71 |  |  |  |  |
| 2534 | 1.8.10.1.2.3 | Development of Implementation Group |  | 59d | 2025-04-28 | 2025-07-17 |  |  |  | 2025-04-28 | 2025-07-17 | 59d |  |  | 34d | 0d | start no earlier than 2025-04-28 |  | SI Transition | SI Transition | Transition | 6.11 | Matthew Breen |  | Green | GREEN | 152.33 |  |  |  |  |
| 2535 | 1.8.10.1.2.4 | Implementation Group Established | milestone | 0d | 2025-07-17 | 2025-07-17 | 2534 |  |  | 2025-07-17 | 2025-07-17 | 0d |  |  | 34d | 0d |  |  | SI Transition | SI Transition | Transition | 6.11 | Matthew Breen |  | Green | GREEN | 232.71 |  |  |  |  |
| 2536 | 1.8.10.1.2.5 | Finalised Cutover Comms Approach shared | milestone | 0d | 2025-08-14 | 2025-08-14 | 2533FS+20d, 2535FS+20d |  |  | 2025-08-14 | 2025-08-14 | 0d |  |  | 34d | 28d |  |  | SI Transition | SI Transition | Transition | 6.11 | Matthew Breen |  | Green | GREEN | 260.71 |  |  |  |  |
| 2537 | 1.8.10.1.3 | **Development of Cutover Plan requirements with Participants** |  | 94d | 2025-04-28 | 2025-09-04 |  |  |  | 2025-03-03 | 2025-08-06 | 59d |  |  | 19d |  |  |  | N/A | N/A | Transition | 6.11 | N/A |  |  |  | -605.67 |  |  |  |  |
| 2538 | 1.8.10.1.3.1 | Development of SIT Participant Cutover Plans |  | 59d | 2025-04-28 | 2025-07-17 |  |  |  | 2025-04-28 | 2025-07-17 | 59d |  |  | 19d | 0d | start no earlier than 2025-04-28 |  | SI Transition | SI Transition | Transition | 6.11 | Matthew Breen |  | Green | GREEN | 152.33 |  |  |  |  |
| 2539 | 1.8.10.1.3.2 | SIT Participant Cutover Plans Ready | milestone | 0d | 2025-07-17 | 2025-07-17 | 2538 |  |  | 2025-07-17 | 2025-07-17 | 0d |  |  | 19d | 0d |  |  | SI Transition | SI Transition | Transition | 6.11 | Matthew Breen |  | Green | GREEN | 232.71 |  |  |  |  |
| 2540 | 1.8.10.1.3.3 | Programme SIT Participant Cutover Plan Assurance |  | 35d | 2025-07-18 | 2025-09-04 | 2539 |  |  | 2025-07-18 | 2025-09-17 | 44d |  |  | 19d | 13d |  |  | SI Transition | SI Transition | Transition | 6.11 | Matthew Breen |  | Green | GREEN | 233.33 |  |  |  |  |
| 2541 | 1.8.10.1.4 | **M10/M11 Cutover Activities** |  | 15d | 2025-09-05 | 2025-09-26 |  |  |  | 2025-04-14 | 2025-09-26 | 15d |  |  | 12d |  |  | -0 |  |  | Transition | 6.11 |  |  |  |  | -608.67 |  |  |  |  |
| 2542 | 1.8.10.1.4.1 | Production DIP Portal (DIP Deployment) | milestone | 0d | 2025-09-05 | 2025-09-05 | 1575FS+10d |  |  | 2025-09-05 | 2025-09-05 | 0d |  |  | 12d | 6d |  |  | Elexon,DIP Manager | Elexon,DIP Manager, SI Transition | Transition | 6.11 | Matthew Breen |  | Green | GREEN | 282.71 |  |  |  |  |
| 2543 | 1.8.10.1.4.2 | Production Certificates (DIP Deployment) | milestone | 0d | 2025-09-05 | 2025-09-05 | 1575FS+10d |  |  | 2025-09-05 | 2025-09-05 | 0d |  |  | 12d | 6d |  |  | Elexon,DIP Manager | Elexon,DIP Manager, SI Transition | Transition | 6.11 | Matthew Breen |  | Green | GREEN | 282.71 |  |  |  |  |
| 2544 | 1.8.10.1.4.3 | Completion of the pre-M10 MHHS Data Cleanse | milestone | 0d | 2025-09-23 | 2025-09-23 | 1712 |  |  | 2025-09-24 | 2025-09-24 | 0d |  |  | 587d |  |  |  | PP,DCC,SI Transition | PP,DCC,SI Transition | Transition | 6.11 | Matthew Breen |  | Green | GREEN | 300.71 |  |  |  |  |
| 2545 | 1.8.10.1.4.4 | Market-wide Participant MHHS Supporting Functionality Ready - Confirmation from Code Bodies | milestone | 0d | 2025-09-12 | 2025-09-12 | 1712FS-8d |  |  | 2025-09-15 | 2025-09-15 | 0d |  |  | 595d |  |  |  | Code Bodies | Code Bodies,SI Transition | Transition | 6.11 | Matthew Breen |  | Green | GREEN | 289.33 |  |  |  |  |
| 2546 | 1.8.10.1.4.5 | Market-wide Participant MHHS Supporting Functionality Ready | milestone | 0d | 2025-09-19 | 2025-09-19 | 1712FS-3d |  |  | 2025-09-22 | 2025-09-22 | 0d |  |  | 590d |  |  |  | PP | PP,SI Transition | Transition | 6.11 | Matthew Breen |  | Green | GREEN | 296.33 |  |  |  |  |
| 2547 | 1.8.10.1.4.6 | Elexon Central Services Deployment | milestone | 0d | 2025-09-18 | 2025-09-18 | 2569 |  |  | 2025-09-19 | 2025-09-19 | 0d |  |  | 6d | 0d |  |  | DIP Manager,Elexon | DIP Manager,Elexon,SI Transition | Transition | 6.11 | Matthew Breen |  | Green | GREEN | 295.71 |  |  |  |  |
| 2548 | 1.8.10.1.4.7 | Service Management Go-Live | milestone | 0d | 2025-09-18 | 2025-09-18 | 2569 |  |  | 2025-09-19 | 2025-09-19 | 0d |  |  | 6d | 0d |  |  | Elexon | Elexon,SI Transition | Transition | 6.11 | Matthew Breen |  | Green | GREEN | 295.71 |  |  |  |  |
| 2549 | 1.8.10.1.4.8 | Data Transfer Service (DTS) New Functionality Deployment | milestone | 0d | 2025-09-18 | 2025-09-18 | 2569 |  |  | 2025-09-19 | 2025-09-19 | 0d |  |  | 6d | 0d |  |  | Code Bodies,Electralink | Code Bodies,SI Transition | Transition | 6.11 | Matthew Breen |  | Green | GREEN | 295.71 |  |  |  |  |
| 2550 | 1.8.10.1.4.9 | Electricity Enquiry Service (EES) Deployment | milestone | 0d | 2025-09-18 | 2025-09-18 | 2569 |  |  | 2025-09-19 | 2025-09-19 | 0d |  |  | 6d | 0d |  |  | Code Bodies | Code Bodies,SI Transition | Transition | 6.11 | Matthew Breen |  | Green | GREEN | 295.71 |  |  |  |  |
| 2551 | 1.8.10.1.4.10 | MPRS, UMSO Role, LDSO Role Operational | milestone | 0d | 2025-09-18 | 2025-09-18 | 2569 |  |  | 2025-09-19 | 2025-09-19 | 0d |  |  | 6d | 0d |  |  | PP | SI Transition,PP | Transition | 6.11 | Matthew Breen |  | Green | GREEN | 295.71 |  |  |  |  |
| 2552 | 1.8.10.1.4.11 | Population of Domestic Premises Indicator | milestone | 0d | 2025-09-18 | 2025-09-18 | 2569 |  |  | 2025-09-19 | 2025-09-19 | 0d |  |  | 6d | 0d |  |  | PP,DCC,SI Transition | PP,DCC,SI Transition | Transition | 6.11 | Matthew Breen |  | Green | GREEN | 295.71 |  |  |  |  |
| 2553 | 1.8.10.1.4.12 | Population of Market Segment | milestone | 0d | 2025-09-18 | 2025-09-18 | 2569 |  |  | 2025-09-19 | 2025-09-19 | 0d |  |  | 6d | 0d |  |  | PP,SI Transition | PP,SI Transition | Transition | 6.11 | Matthew Breen |  | Green | GREEN | 295.71 |  |  |  |  |
| 2554 | 1.8.10.1.4.13 | Early Life Support Implemented | milestone | 0d | 2025-09-18 | 2025-09-18 | 2569 |  |  | 2025-09-19 | 2025-09-19 | 0d |  |  | 9d | 3d |  |  | SI Transition,Elexon,Central Services | SI Transition,Elexon,Central Services | Transition | 6.11 | Matthew Breen |  | Green | GREEN | 295.71 |  |  |  |  |
| 2555 | 1.8.10.1.4.14 | MCC Tested and Ready to Operate | milestone | 0d | 2025-09-19 | 2025-09-19 |  |  |  | 2025-09-19 | 2025-09-19 | 0d |  |  | 590d | 0d | start no earlier than 2025-09-19 |  | SI Migration | SI Migration | Transition | 6.11 | Matthew Breen |  | Green | GREEN | 296.33 |  |  |  | 1/7: To link into migration/service activation |
| 2556 | 1.8.10.1.4.15 | MCC Operational | milestone | 0d | 2025-09-19 | 2025-09-19 | 2555 |  |  | 2025-09-19 | 2025-09-19 | 0d |  |  | 590d |  |  |  | SI Migration | SI Migration | Transition | 6.11 | Matthew Breen |  | Green | GREEN | 296.33 |  |  |  | 1/7: To link into migration/service activation |
| 2557 | 1.8.4.1.4 | Central Systems live and Codes designated at 00:00 | milestone | 0d | 2025-09-19 | 2025-09-19 | 2547FS+1d, 2548FS+1d, 2549FS+1d, 2550FS+1d, 2551FS+1d, 2552FS+1d, 2553FS+1d, 2530FS+1d |  |  | 2025-09-22 | 2025-09-22 | 0d |  |  | 6d | 0d |  |  | SI Transition | SI Transition | Transition | 6.11 | Matthew Breen |  | Green | GREEN | 296.71 | T3-MI-0034 | MCAG (Transition) |  |  |
| 2558 | 1.8.10.1.4.17 | SIT Participant Qualification - The final date by which participant qualification status can be confirmed for participants to be ready for the start of Migration at M11. | milestone | 0d | 2025-09-26 | 2025-09-26 | 1575FS+25d |  |  | 2025-09-26 | 2025-09-26 | 0d |  |  | 19d | 10d |  |  | PP,Code Bodies,BSC PAB | SI Transition,PP,Code Bodies,BSC PAB | Transition | 6.11 | Matthew Breen |  | Green | GREEN | 303.71 |  |  |  |  |

Notes:
- 2527: 12/11/24 - Production of this artefact has been delayed pending discussion on outstanding artefacts to be produced through TORWG.
- 2545: 09/10/24 - WR and Fola O extended duration by 110d so the activity completes at 04/08/25.
- 2546: 09/10/24 - WR and Fola O reduced the lag so the activity completes at 11/08/25.
- 2557: Guidance: 25/7/24: New Milestone approved at MCAG on 25/7/24. It was initially approved at MCAG on 4/6 but didn't follow the usual process so addded to July MCAG for noting

| ID | WBS | Task | Type | Duration | Start | Finish | Predecessors | Baseline start | Baseline finish | Baseline duration | Total slack | Free slack | Constraint | Responsible | Involved | Text9 | Task Status | Update Version | MHHS Resource Name | Sched Status | RAG | Milestone ID | Text29 |
| --- | --- | --- | --- | --- | --- | --- | --- | --- | --- | --- | --- | --- | --- | --- | --- | --- | --- | --- | --- | --- | --- | --- | --- |
| 2559 | 1.8.10.2 | **Cutover Governance M10** |  | 10d | 2025-09-10 | 2025-09-23 |  | 2025-07-30 | 2025-09-24 | 27d | 9d |  |  | N/A | N/A | Transition | -595.67 | 6.11 | N/A |  |  |  |  |
| 2560 | 1.8.10.2.1 | Confirmation that Pre-migration Data Cleanse Activities have successfully taken place | milestone | 0d | 2025-09-10 | 2025-09-10 |  | 2025-09-10 | 2025-09-10 | 0d | 10d | 4d | start no earlier than 2025-09-10 | PP | SI Transition,PP | Transition | 287.33 | 6.11 | Matthew Breen | Green | GREEN |  |  |
| 2561 | 1.8.10.2.2 | Confirmation of Helix E2E Settlement Testing Complete | milestone | 0d | 2025-09-15 | 2025-09-15 |  | 2025-09-15 | 2025-09-15 | 0d | 7d | 1d | start no earlier than 2025-09-15 |  |  | Transition | 292.33 | 6.11 |  | Green | GREEN |  |  |
| 2562 | 1.8.10.2.3 | Confirmation of assurance of Helix E2E Settlement Testing | milestone | 0d | 2025-09-15 | 2025-09-15 |  | 2025-09-15 | 2025-09-15 | 0d | 7d | 1d | start no earlier than 2025-09-15 |  |  | Transition | 292.33 | 6.11 |  | Green | GREEN |  |  |
| 2563 | 1.8.10.2.4 | Confirmation of Qualification Status for SIT MVC | milestone | 0d | 2025-09-15 | 2025-09-15 |  | 2025-09-15 | 2025-09-15 | 0d | 7d | 1d | start no earlier than 2025-09-15 | SIT MVC,Code Bodies | SI Transition,SIT MVC,Code Bodies | Transition | 292.33 | 6.11 | Matthew Breen | Green | GREEN |  |  |
| 2564 | 1.8.10.2.5 | Confirmation of Qualification Status for Non-SIT LDSOs | milestone | 0d | 2025-09-15 | 2025-09-15 |  | 2025-09-15 | 2025-09-15 | 0d | 7d | 1d | start no earlier than 2025-09-15 | PP,Code Bodies | SI Transition,PP,Code Bodies | Transition | 292.33 | 6.11 | Matthew Breen | Green | GREEN |  |  |
| 2565 | 1.8.10.2.6 | Confirmation of Qualification Status of at least one Supplier and their contracted Agents | milestone | 0d | 2025-09-15 | 2025-09-15 |  | 2025-09-15 | 2025-09-15 | 0d | 7d | 1d | start no earlier than 2025-09-15 | S&A Qualification | SI Transition,S&A Qualification | Transition | 292.33 | 6.11 | Matthew Breen | Green | GREEN |  |  |
| 2566 | 1.8.10.2.7 | Declaration from all Central Services and LDSOs that they are in a position to move forwards | milestone | 0d | 2025-09-15 | 2025-09-15 |  | 2025-09-15 | 2025-09-15 | 0d | 8d | 2d | start no earlier than 2025-09-15 | DIP Manager,Elexon,PP,Code Bodies | SI Transition,DIP Manager,Elexon,PP,Code Bodies | Transition | 292.33 | 6.11 | Matthew Breen | Green | GREEN |  |  |
| 2567 | 1.8.10.2.8 | Market-wide Participant MHHS Migration Supporting Functionality is Live | milestone | 0d | 2025-09-15 | 2025-09-15 |  | 2025-09-15 | 2025-09-15 | 0d | 8d | 2d | start no earlier than 2025-09-15 |  |  | Transition | 292.33 | 6.11 |  | Green | GREEN |  |  |
| 2568 | 1.8.10.2.9 | TORWG (Recommendation from TORWG that the Programme should enter M10) | milestone | 0d | 2025-09-16 | 2025-09-16 | 2560FS+1d, 2563FS+1d, 2565FS+1d, 2542FS+1d, 2543FS+1d, 2651FS+1d, 2561FS+1d, 2562FS+1d, 2564FS+1d, 2566, 2567 | 2025-09-17 | 2025-09-17 | 0d | 6d | 0d |  | SI Transition | SI Transition | Transition | 293.71 | 6.11 | Matthew Breen | Green | GREEN |  |  |
| 2569 | 1.8.4.1.4 | MCAG (Confirm that the Programme can Enter M10) | milestone | 0d | 2025-09-18 | 2025-09-18 | 2568FS+2d, 2657 | 2025-09-19 | 2025-09-19 | 0d | 6d | 0d |  | SI Migration | SI Transition,SI Migration | Transition | 295.71 | 6.11 | Matthew Breen | Green | GREEN | T3-MI-0035 | MCAG (Transition) |
| 2570 | 1.8.10.2.11 | Self-Declaration from all Central Services and LDSOs that Cutover activities have been successfully carried out | milestone | 0d | 2025-09-19 | 2025-09-19 | 2569FS+1d | 2025-09-22 | 2025-09-22 | 0d | 9d | 0d |  | PP,DCC,Code Bodies | SI Transition,PP,DCC,Code Bodies | Transition | 296.71 | 6.11 | Matthew Breen | Green | GREEN |  |  |
| 2571 | 1.8.10.2.12 | Confirmation that DIP and ECS have been deployed, Service management is active, ISD has been populated | milestone | 0d | 2025-09-19 | 2025-09-19 | 2569FS+1d | 2025-09-22 | 2025-09-22 | 0d | 9d | 0d |  | Elexon,DIP Manager | SI Transition,Elexon,DIP Manager | Transition | 296.71 | 6.11 | Matthew Breen | Green | GREEN |  |  |
| 2572 | 1.8.10.2.13 | Self-Declarations against all M10 Data Cleanse Activities | milestone | 0d | 2025-09-19 | 2025-09-19 | 2569FS+1d | 2025-09-22 | 2025-09-22 | 0d | 9d | 0d |  | PP | SI Transition,PP | Transition | 296.71 | 6.11 | Matthew Breen | Green | GREEN |  |  |
| 2573 | 1.8.10.2.14 | IF-047 has been sent | milestone | 0d | 2025-09-19 | 2025-09-19 | 2569FS+1d | 2025-09-22 | 2025-09-22 | 0d | 9d | 0d |  | ECS | SI Transition,ECS | Transition | 296.71 | 6.11 | Matthew Breen | Green | GREEN |  |  |
| 2574 | 1.8.10.2.15 | Recommendation from TORWG that PSG should approve M10 | milestone | 0d | 2025-09-22 | 2025-09-22 | 2570FS+1d, 2571FS+1d, 2572FS+1d, 2573FS+1d, 2655 | 2025-09-23 | 2025-09-23 | 0d | 9d | 0d |  | SI Transition | SI Transition | Transition | 299.71 | 6.11 | Matthew Breen | Green | GREEN |  |  |
| 2575 | 1.8.10.2.16 | PSG (OFGEM and PSG to Approve That Conditions of M10 and M13 Have Been Met) | milestone | 0d | 2025-09-23 | 2025-09-23 | 2574FS+1d | 2025-09-24 | 2025-09-24 | 0d | 9d | 0d |  | SI Transition,Ofgem | SI Transition,Ofgem | Transition | 300.71 | 6.11 | Matthew Breen | Green | GREEN |  |  |
| 2576 | 1.8.10.3 | **Cutover Governance M11** |  | 16d | 2025-09-25 | 2025-10-16 |  | 2025-09-26 | 2025-10-22 | 0d | 9d |  |  |  |  | Transition | -687.67 | 6.11 |  |  |  |  |  |
| 2577 | 1.8.10.3.1 | Confirmation of Qualified Parties from Code Bodies |  | 11d | 2025-09-25 | 2025-10-09 | 2575FS+1d | 2025-09-26 | 2025-10-10 | 11d | 9d | 0d |  | Code Bodies,SIT Participants | SI Transition,Code Bodies,SIT Participants | Transition | 302.33 | 6.11 | Matthew Breen | Green | GREEN |  |  |
| 2578 | 1.8.10.3.2 | Self-Declaration that MHHS Functionality will be deployed to Production by Qualified parties | milestone | 0d | 2025-10-09 | 2025-10-09 | 2575FS+12d | 2025-10-10 | 2025-10-10 | 0d | 9d | 0d |  | PP | SI Transition,PP | Transition | 316.71 | 6.11 | Matthew Breen | Green | GREEN |  |  |
| 2579 | 1.8.10.3.3 | Production Service Activation Activities have taken place | milestone | 0d | 2025-10-09 | 2025-10-09 | 2575FS+12d | 2025-10-10 | 2025-10-10 | 0d | 9d | 0d |  | PP | SI Transition,PP | Transition | 316.71 | 6.11 | Matthew Breen | Green | GREEN |  |  |
| 2580 | 1.8.10.3.4 | TORWG (Confirmation of Qualified Parties from TORWG) | milestone | 0d | 2025-10-10 | 2025-10-10 | 2577FS+1d, 2578FS+1d, 2579FS+1d, 2558, 2652, 2656 | 2025-10-13 | 2025-10-13 | 0d | 9d | 0d |  | SI Transition | SI Transition | Transition | 317.71 | 6.11 | Matthew Breen | Green | GREEN |  |  |
| 2581 | 1.8.10.3.5 | MCAG (Provide recommendation to PSG on M11 decision) | milestone | 0d | 2025-10-14 | 2025-10-14 | 2580FS+2d | 2025-10-15 | 2025-10-15 | 0d | 9d | 0d |  | SI Migration | SI Transition,SI Migration | Transition | 321.71 | 6.11 | Matthew Breen | Green | GREEN | T3-MI-0036 | MCAG (Transition) |
| 2582 | 1.8.10.3.6 | PSG (OFGEM and PSG Decision to Confirm M11 and M12) | milestone | 0d | 2025-10-16 | 2025-10-16 | 2581FS+2d | 2025-10-17 | 2025-10-17 | 0d | 9d | 3d |  | SI Transition | SI Transition | Transition | 323.71 | 6.11 | Matthew Breen | Green | GREEN |  |  |

Notes:
- 2569: Guidance: 25/7/24: New Milestone approved at MCAG on 25/7/24. It was initially approved at MCAG on 4/6 but didn't follow the usual process so addded to July MCAG for noting
- 2579: Guidance: 12/8/24: Think this is covered in Service activation prep section below
- 2581: Guidance: 25/7/24: New Milestone approved at MCAG on 25/7/24. It was initially approved at MCAG on 4/6 but didn't follow the usual process so addded to July MCAG for noting

| ID | WBS | Task | Type | Duration | Start | Finish | Predecessors | Complete | Remaining | Baseline start | Baseline finish | Baseline duration | Baseline 1 start | Baseline 1 finish | Total slack | Free slack | Constraint | Baseline cost | Responsible | Involved | Text9 | Task Status | Update Version | MHHS Resource Name | Sched Status | RAG | MHHS Programme Phase |
| --- | --- | --- | --- | --- | --- | --- | --- | --- | --- | --- | --- | --- | --- | --- | --- | --- | --- | --- | --- | --- | --- | --- | --- | --- | --- | --- | --- |
| 2583 | 1.8.11 | **UMS / Advanced Migration** |  | 402d | 2025-10-22 | 2027-05-06 |  |  |  | 2025-10-23 | 2027-05-07 | 391d |  |  | 1d |  |  | -0 | N/A | N/A | Transition | -555.67 | 6.0 | N/A |  |  |  |
| 2584 | 1.8.11.1 | SIT MVC UMS / Advanced Migration |  | 391d | 2025-10-22 | 2027-04-21 | 2657, 2613 |  |  | 2025-10-23 | 2027-04-22 | 391d |  |  | 12d | 0d |  |  |  |  | Transition | 329.33 | 6.0 |  | Green | GREEN |  |
| 2585 | 1.8.11.2 | SIT Non-MVC UMS / Advanced Migration |  | 326d | 2025-12-29 | 2027-03-29 | 2680 |  |  | 2026-01-02 | 2027-04-02 | 326d |  |  | 29d |  |  |  |  |  | Transition | 397.33 | 6.0 |  | Green | GREEN |  |
| 2586 | 1.8.11.3 | Wave 1 UMS / Advanced Migration |  | 251d | 2026-05-15 | 2027-04-30 | 2696 |  |  | 2026-05-15 | 2027-04-30 | 261d |  |  | 5d |  |  |  |  |  | Transition | 534.33 | 6.0 |  | Green | GREEN |  |
| 2587 | 1.8.11.4 | Wave 2 UMS / Advanced Migration |  | 217d | 2026-07-02 | 2027-04-30 | 2720 |  |  | 2026-07-01 | 2027-04-29 | 216d |  |  | 5d |  |  |  |  |  | Transition | 582.33 | 6.0 |  | yellow | RED |  |
| 2588 | 1.8.11.5 | Wave 3 UMS / Advanced Migration |  | 182d | 2026-08-14 | 2027-04-26 | 2744 |  |  | 2026-08-27 | 2027-05-07 | 181d |  |  | 9d |  |  |  |  |  | Transition | 625.33 | 6.0 |  | Green | GREEN |  |
| 2589 | 1.8.11.6 | Wave 4 UMS / Advanced Migration |  | 136d | 2026-10-29 | 2027-05-06 | 2768 |  |  | 2026-10-23 | 2027-04-30 | 131d |  |  | 1d |  |  |  |  |  | Transition | 701.33 | 6.0 |  | yellow | RED |  |
| 2590 | 1.8.12 | **Smart / Non-Smart Migration** |  | 402d | 2025-10-22 | 2027-05-06 |  |  |  | 2025-10-23 | 2027-05-07 | 391d |  |  | 1d |  |  | -0 | N/A | N/A | Transition | -555.67 | 6.0 | N/A |  |  |  |
| 2591 | 1.8.12.1 | SIT MVC Smart / Non-Smart Migration |  | 391d | 2025-10-22 | 2027-04-21 | 2657, 2613 |  |  | 2025-10-23 | 2027-04-22 | 391d |  |  | 12d | 0d |  |  |  |  | Transition | 329.33 | 6.0 |  | Green | GREEN |  |
| 2592 | 1.8.12.2 | SIT Non-MVC Smart / Non-Smart Migration |  | 326d | 2025-12-29 | 2027-03-29 | 2680 |  |  | 2026-01-02 | 2027-04-02 | 326d |  |  | 29d |  |  |  |  |  | Transition | 397.33 | 6.0 |  | Green | GREEN |  |
| 2593 | 1.8.12.3 | Wave 1 Smart / Non-Smart Migration |  | 251d | 2026-05-15 | 2027-04-30 | 2696 |  |  | 2026-05-15 | 2027-04-30 | 261d |  |  | 5d |  | start no earlier than 2025-10-03 |  |  |  | Transition | 534.33 | 6.0 |  | Green | GREEN |  |
| 2594 | 1.8.12.4 | Wave 2 Smart / Non-Smart Migration |  | 217d | 2026-07-02 | 2027-04-30 | 2720 |  |  | 2026-07-01 | 2027-04-29 | 216d |  |  | 5d |  |  |  |  |  | Transition | 582.33 | 6.0 |  | yellow | RED |  |
| 2595 | 1.8.12.5 | Wave 3 Smart / Non-Smart Migration |  | 182d | 2026-08-14 | 2027-04-26 | 2744 |  |  | 2026-08-27 | 2027-05-07 | 181d |  |  | 9d |  |  |  |  |  | Transition | 625.33 | 6.0 |  | Green | GREEN |  |
| 2596 | 1.8.12.6 | Wave 4 Smart / Non-Smart Migration |  | 136d | 2026-10-29 | 2027-05-06 | 2768 |  |  | 2026-10-23 | 2027-04-30 | 131d |  |  | 0d |  |  |  |  |  | Transition | 701.33 | 6.0 |  | yellow | RED |  |
| 2597 | 1.8.13 | **External Programme Dependency Management** |  | 739d | 2022-10-31 A | 2025-08-28 |  | 66% | 253.09d | 2022-10-31 | 2025-08-29 | 827d | 2022-10-31 | 2025-07-01 | 605d |  |  | -0 | N/A | N/A | Transition |  | 5.0 | N/A |  |  | Migration |
| 2598 | 1.8.13.1 | **BSC Mod P432 & REC CP R0015** |  | 392d | 2022-10-31 A | 2024-04-30 A |  | 100% |  | 2022-10-31 | 2024-04-30 | 827d | 2022-10-31 | 2025-07-01 |  |  |  | -0 | N/A | N/A | Transition |  | 5.0 | N/A |  |  | Migration |
| 2599 | 1.8.13.1.1 | MHHSP engagement with BSCCo until Ofgem decision |  | 316d | 2022-10-31 A | 2024-01-15 A |  | 100% |  | 2022-10-31 | 2024-01-15 | 400d | 2022-10-31 | 2022-12-30 |  |  |  |  | CPT,SRO Function | Code Bodies | Transition |  | 5.0 | MHHS Programme | Complete | COMPLETE | Migration |
| 2600 | 1.8.13.1.2 | Monitor progress and await implementation date |  | 76d | 2024-01-16 A | 2024-04-30 A | 2599 | 100% |  | 2024-01-16 | 2024-04-30 | 652d | 2023-01-02 | 2025-07-01 |  |  |  |  | CPT,SRO Function | Code Bodies | Transition |  | 5.0 | MHHS Programme | Complete | COMPLETE | Migration |
| 2601 | 1.8.13.2 | **BSC Mod P434** |  | 713d | 2022-10-31 A | 2025-07-23 |  | 57% | 310d | 2022-10-31 | 2025-07-23 | 713d | 2022-10-31 | 2025-07-01 | 631d |  |  |  | N/A | N/A | Transition |  | 5.0 | N/A |  |  | Migration |
| 2602 | 1.8.13.2.1 | MHHSP engagement with BSCCo until Ofgem decision |  | 61d | 2022-10-31 A | 2023-01-23 A |  | 100% |  | 2022-10-31 | 2023-01-23 | 61d | 2022-10-31 | 2022-12-30 |  |  |  |  | CPT,SRO Function | Code Bodies | Transition |  | 5.0 | MHHS Programme | Complete | COMPLETE | Migration |
| 2603 | 1.8.13.2.2 | Monitor progress and await implementation date |  | 652d | 2023-01-24 A | 2025-07-23 | 2602 | 52% | 310d | 2023-01-24 | 2025-07-23 | 652d | 2023-01-02 | 2025-07-01 | 631d |  |  |  | CPT,SRO Function | Code Bodies | Transition |  | 5.0 | MHHS Programme | Green | GREEN | Migration |
| 2604 | 1.8.13.3 | **Elexon System Capacity Upgrade** |  | 697d | 2022-10-31 A | 2025-07-01 |  | 58% | 294d | 2022-10-31 | 2025-07-01 | 697d | 2022-10-31 | 2025-07-01 | 647d |  |  |  | N/A | N/A | Transition |  | 5.0 | N/A |  |  | Migration |
| 2605 | 1.8.13.3.1 | Monitor progress to implementation |  | 697d | 2022-10-31 A | 2025-07-01 |  | 58% | 294d | 2022-10-31 | 2025-07-01 | 697d | 2022-10-31 | 2025-07-01 | 647d | 0d |  |  | SI Migration | PP | Transition |  | 5.0 | MHHS Programme | Green | GREEN | Migration |
| 2606 | 1.8.13.3.2 | Implementation date | milestone | 0d | 2025-07-01 | 2025-07-01 | 2605 |  |  | 2025-07-01 | 2025-07-01 | 0d | 2025-07-01 | 2025-07-01 | 647d |  |  |  | PP | SI Migration | Transition | 216.71 | 5.0 | MHHS Programme | Green | GREEN | Migration |

Notes:
- 2586: Guidance: 12/8/24: Made start no earlier, because shorter service actiobal was allowing this to start earlier than the date that had been set
- 2593: Guidance: 12/8/24: Made start no earlier, because shorter service actiobal was allowing this to start earlier than the date that had been set

| ID | WBS | Task | Type | Duration | Start | Finish | Predecessors | Complete | Remaining | Baseline start | Baseline finish | Baseline duration | Baseline 1 start | Baseline 1 finish | Total slack | Free slack | Constraint | Baseline cost | Responsible | Involved | Text9 | Update Version | MHHS Resource Name | MHHS Programme Phase | Task Status | Sched Status | RAG | Milestone ID | Text29 | Tier | Future RAG |
| --- | --- | --- | --- | --- | --- | --- | --- | --- | --- | --- | --- | --- | --- | --- | --- | --- | --- | --- | --- | --- | --- | --- | --- | --- | --- | --- | --- | --- | --- | --- | --- |
| 2607 | 1.8.13.4 | **DCC System Capacity Upgrade** |  | 25d | 2025-07-25 | 2025-08-28 |  |  |  | 2025-07-28 | 2025-08-29 | 25d | 2025-01-13 | 2025-02-14 | 605d |  |  |  | N/A | N/A | Transition | 5.0 | N/A | Migration |  |  |  |  |  |  |  |
| 2608 | 1.8.13.4.1 | Assurance of DCC capacity upgrade to ensure suitability to support migration |  | 20d | 2025-07-25 | 2025-08-21 | 1712FF-23d |  |  | 2025-07-28 | 2025-08-22 | 20d | 2025-01-13 | 2025-02-07 | 605d | 0d |  |  | SI Migration | PP | Transition | 5.0 | MHHS Programme | Migration | 240.33 | Green | GREEN |  |  |  |  |
| 2609 | 1.8.13.4.2 | DCC Capacity Upgrade Operational | milestone | 0d | 2025-08-28 | 2025-08-28 | 2608FS+5d |  |  | 2025-08-29 | 2025-08-29 | 0d | 2025-02-14 | 2025-02-14 | 605d |  |  |  | PP | SI Migration,IPA | Transition | 5.0 | MHHS Programme | Migration | 274.71 | Green | GREEN | T2-MI-0350 | MCAG | T2 |  |
| 2610 | 1.8.14 | **Migration - Tier 1 Milestones** |  | 489d | 2025-09-23 | 2027-08-09 |  |  |  | 2025-09-24 | 2027-08-09 | 477d | 2025-03-07 | 2027-01-05 | 26d |  |  |  | N/A | N/A | Transition | 5.0 | N/A | Migration |  |  |  |  |  |  |  |
| 2611 | 1.8.14.1 | Load Shaping Service switched on (M13) | milestone | 0d | 2025-09-23 | 2025-09-23 | 1712 |  |  | 2025-09-24 | 2025-09-24 | 0d | 2025-03-07 | 2025-03-07 | 26d | 0d |  |  | CPT | CPT | Transition | 6.1 | CPT | Migration | 300.71 | Green | GREEN | T1-MI-2000 | PSG | T1 | Load Shaping Service switched on |
| 2612 | 1.8.14.2 | Load Shaping Service switched on (M13*) - Late Exit | milestone | 0d | 2025-12-23 | 2025-12-23 | 2611FS+65d |  |  | 2025-12-24 | 2025-12-24 | 0d | 2025-06-06 | 2025-06-06 | 522d |  |  |  | CPT | CPT | Transition | 6.1 | CPT | Migration | 391.71 | Green | GREEN | T2-MI-2500 | PSG | T1 | Load Shaping Service switched on |
| 2613 | 1.8.14.3 | Start of 18-month migration for UMS / Advanced (M11) | milestone | 0d | 2025-10-21 | 2025-10-21 | 2611, 2581, 2582, 2657, 1712FS+20d |  |  | 2025-10-22 | 2025-10-22 | 0d | 2025-04-04 | 2025-04-04 | 6d | 0d |  |  | CPT | CPT | Transition | 6.1 | CPT | Migration | 328.71 | Green | GREEN | T1-MI-3000 | PSG | T1 | Start of 1 year migration for UMS / Advanced |
| 2614 | 1.8.14.4 | Start of 18-month migration for UMS / Advanced (M11*) - Late Exit | milestone | 0d | 2026-01-20 | 2026-01-20 | 2613FS+65d |  |  | 2026-01-21 | 2026-01-21 | 0d | 2025-07-04 | 2025-07-04 | 502d |  |  |  | CPT | CPT | Transition | 6.1 | CPT | Migration | 419.71 | Green | GREEN | T2-MI-3500 | PSG | T1 | Start of 1 year migration for UMS / Advanced |
| 2615 | 1.8.14.5 | Start of 18-month migration for Smart / Non-smart (M12) | milestone | 0d | 2025-10-21 | 2025-10-21 | 2611, 1712FS+20d |  |  | 2025-10-22 | 2025-10-22 | 0d | 2025-04-04 | 2025-04-04 | 502d | 0d |  |  | CPT | CPT | Transition | 6.1 | CPT | Migration | 328.71 | Green | GREEN | T1-MI-4000 | PSG | T1 | Start of 1 year migration for Smart / Non-smart |
| 2616 | 1.8.14.6 | Start of 18-month migration for Smart / Non-smart (M12*) - Late Exit | milestone | 0d | 2026-01-20 | 2026-01-20 | 2615FS+65d |  |  | 2026-01-21 | 2026-01-21 | 0d | 2025-07-04 | 2025-07-04 | 502d |  |  |  | CPT | CPT | Transition | 6.1 | CPT | Migration | 419.71 | Green | GREEN | T2-MI-4500 | PSG | T1 | Start of 1 year migration for Smart / Non-smart |
| 2617 | 1.8.14.7 | Full transition complete (M15) | milestone | 0d | 2027-05-07 | 2027-05-07 | 2584, 2585, 2586, 2587, 2588, 2589, 2591, 2592, 2593, 2594, 2595, 2596FS+1d |  |  | 2027-05-07 | 2027-05-07 | 0d | 2026-10-05 | 2026-10-05 | 0d |  |  |  | CPT | CPT | Transition | 6.1 | CPT | Migration | 891.71 | Green | GREEN | T1-MI-6000 | PSG | T1 | Full transition complete |
| 2618 | 1.8.14.8 | Full transition complete (M15*) - Late Exit | milestone | 0d | 2027-08-09 | 2027-08-09 | 2617FS+66d |  |  | 2027-08-09 | 2027-08-09 | 0d | 2027-01-05 | 2027-01-05 | 98d |  |  |  | CPT | CPT | Transition | 6.1 | CPT | Migration | 985.71 | Green | GREEN | T2-MI-6500 | PSG | T1 | Full transition complete |
| 2619 | 1.9 | **BUSINESS & OPERATIONAL READINESS** |  | 1344d? | 2022-10-31 A | 2027-12-23 |  | 6% | 1268.57d? | 2022-10-31 | 2027-12-23 | 964d | 2023-03-01 | 2026-12-07 | 0d |  |  | -0 | N/A | N/A | Business & Operation Readiness |  | N/A | Business & Operational Readiness |  |  |  |  |  |  |  |
| 2620 | 1.9.1 | **Service Management** |  | 982d | 2023-09-19 A | 2027-06-23 |  | 26% | 727.61d | 2023-09-19 | 2027-06-24 | 840d | 2023-03-01 | 2026-12-07 | 131d |  |  | -0 | N/A | N/A | Business & Operation Readiness | 5.0 | N/A | Business & Operational Readiness |  |  |  |  |  |  |  |
| 2621 | 1.9.1.1 | **Service Management Strategy** |  | 116d | 2023-09-19 A | 2024-02-27 A |  | 100% |  | 2023-09-19 | 2024-02-27 | 116d | 2023-03-01 | 2023-05-31 |  |  |  | -0 | N/A | N/A | Business & Operation Readiness | 5.0 | N/A | Business & Operational Readiness |  |  |  |  |  |  |  |
| 2622 | 1.9.1.1.1 | Develop document with relevant participants (incl. review of the design baseline to ensure service management arrangements are in place across the solution architecture) |  | 84d | 2023-09-19 A | 2024-01-12 A |  | 100% |  | 2023-09-19 | 2024-01-12 | 84d | 2023-03-01 | 2023-04-28 |  |  | start no earlier than 2023-09-19 |  | SI Design |  | Business & Operation Readiness | 5.0 | Matthew Breen | Business & Operational Readiness |  | Complete | COMPLETE |  |  |  |  |
| 2623 | 1.9.1.1.2 | Artefact review (via relevant Advisory Group) and updates |  | 31d | 2024-01-15 A | 2024-02-26 A | 2622 | 100% |  | 2024-01-15 | 2024-02-26 | 31d | 2023-05-01 | 2023-05-24 |  |  |  |  | PP | SI Design,IPA | Business & Operation Readiness | 5.0 | Matthew Breen | Business & Operational Readiness |  | Complete | COMPLETE |  |  |  |  |
| 2624 | 1.9.1.1.3 | Service Management Strategy approved | milestone | 0d | 2024-02-27 A | 2024-02-27 A | 2623FS+1d | 100% |  | 2024-02-27 | 2024-02-27 | 0d | 2023-05-31 | 2023-05-31 |  |  |  |  | SI Design | PP | Business & Operation Readiness | 5.16 | Matthew Breen | Business & Operational Readiness |  | Complete | COMPLETE | T3-BC-0010 | MCAG | T3 |  |
| 2625 | 1.9.1.2 | **Early Life Support Model** |  | 110d | 2024-02-28 A | 2024-07-30 |  | 82% | 20.23d | 2024-02-28 | 2024-07-30 | 110d |  |  | 887d |  |  | -0 | N/A | N/A | Business & Operation Readiness | 5.16 | Matthew Breen | Business & Operational Readiness | -441.67 |  |  |  |  |  |  |
| 2626 | 1.9.1.2.1 | Draft Document |  | 74d | 2024-02-28 A | 2024-06-10 | 2624 | 96% | 3d | 2024-02-28 | 2024-06-10 | 74d |  |  | 887d | 0d |  |  | SI Transition | SI Transition,PP,SRO | Business & Operation Readiness | 5.24 | Matthew Breen | Business & Operational Readiness |  | Overdue | RED |  |  |  |  |
| 2627 | 1.9.1.2.2 | Share document with SRO |  | 1d | 2024-06-11 | 2024-06-11 | 2626 |  |  | 2024-06-11 | 2024-06-11 | 1d |  |  | 887d | 0d |  |  | SI Transition | SI Transition,PP,SRO | Business & Operation Readiness | 5.24 | Matthew Breen | Business & Operational Readiness | -168.67 | Overdue Start | RED |  |  |  |  |
| 2628 | 1.9.1.2.3 | Industry Consultation |  | 11d | 2024-06-18 | 2024-07-02 | 2627FS+4d |  |  | 2024-06-18 | 2024-07-02 | 11d |  |  | 887d | 0d |  |  | SI Transition | SI Transition,PP,SRO | Business & Operation Readiness | 5.24 | Matthew Breen | Business & Operational Readiness | -161.67 | Overdue Start | RED |  |  |  |  |
| 2629 | 1.9.1.2.4 | Assurance Meeting |  | 1d | 2024-07-16 | 2024-07-16 | 2628FS+9d |  |  | 2024-07-16 | 2024-07-16 | 1d |  |  | 887d | 0d |  |  | SI Transition | SI Transition,PP,SRO | Business & Operation Readiness | 5.24 | Matthew Breen | Business & Operational Readiness | -133.67 | Overdue Start | RED |  |  |  |  |
| 2630 | 1.9.1.2.5 | MCAG Approval of Early Life Support Model | milestone | 0d | 2024-07-30 | 2024-07-30 | 2629FS+10d |  |  | 2024-07-30 | 2024-07-30 | 0d |  |  | 887d |  |  |  | SI Transition | PP,SRO,SI Transition | Business & Operation Readiness | 5.24 | Matthew Breen | Business & Operational Readiness | -119.29 | Overdue Start | RED | T3-MI-0033 | MCAG (Transition) |  |  |

Notes:
- 2630: 19/11/24 - An update to the revised model and consultation dates will be shared at the December TORWG.

| ID | WBS | Task | Type | Duration | Start | Finish | Predecessors | Baseline start | Baseline finish | Baseline duration | Baseline 1 start | Baseline 1 finish | Total slack | Free slack | Constraint | Baseline cost | Responsible | Involved | Text9 | Update Version | MHHS Resource Name | MHHS Programme Phase | Task Status | Sched Status | RAG |
| --- | --- | --- | --- | --- | --- | --- | --- | --- | --- | --- | --- | --- | --- | --- | --- | --- | --- | --- | --- | --- | --- | --- | --- | --- | --- |
| 2631 | 1.9.1.3 | **Service Management Arrangements Implementation** |  | 456d | 2025-09-24 | 2027-06-23 |  | 2025-09-25 | 2027-06-24 | 453d | 2025-03-10 | 2026-12-07 | 131d |  |  | -0 | N/A | N/A | Business & Operation Readiness | 5.0 | N/A | Business & Operational Readiness |  |  |  |
| 2632 | 1.9.1.3.1 | Hypercare post M10 |  | 80d | 2025-09-24 | 2026-01-13 | 1712 | 2025-09-25 | 2026-01-14 | 80d | 2025-03-10 | 2025-06-27 | 507d |  |  |  | SI Design | PP | Business & Operation Readiness | 5.0 | Claire Silk | Business & Operational Readiness | 301.33 | Green | GREEN |
| 2633 | 1.9.1.3.2 | Monitor Elexon implementation of Service Management arrangements |  | 436d | 2025-10-22 | 2027-06-23 | 2584SS, 2591SS | 2025-10-23 | 2027-06-24 | 436d | 2025-04-07 | 2026-12-07 | 131d |  |  |  | PP | SI Design | Business & Operation Readiness | 5.0 | Claire Silk | Business & Operational Readiness | 329.33 | Green | GREEN |
| 2634 | 1.9.2 | **Service Activation** |  | 1043d? | 2022-10-31 | 2026-10-28 |  | 2022-10-31 | 2026-10-22 | 289d |  |  | 301d |  |  | -0 | N/A | N/A | Business & Operation Readiness | 5.24 | N/A |  | -555.67 |  |  |
| 2635 | 1.9.2.1 | **SIT MVC** |  | 769d? | 2022-10-31 | 2025-10-09 |  | 2025-02-03 | 2025-09-22 | 0d |  |  | 575d |  |  |  |  |  | Business & Operation Readiness | 5.31 |  |  | -650.67 | Overdue Start | RED |
| 2636 | 1.9.2.1.1 | **SIT MVC Service Activation Preparation Tasks** |  | 20d | 2025-02-03 | 2025-02-28 |  | 2025-02-03 | 2025-02-28 | 0d |  |  | 164d |  |  |  |  |  | Business & Operation Readiness | 5.31 |  |  |  |  |  |
| 2637 | 1.9.2.1.1.1 | Identify operational resources |  | 5d | 2025-02-03 | 2025-02-07 |  | 2025-02-03 | 2025-02-07 | 0d |  |  | 749d |  | finish no earlier than 2025-02-07 |  |  |  | Business & Operation Readiness | 5.31 |  |  | 68.33 | Green | GREEN |
| 2638 | 1.9.2.1.1.2 | Define and approve operational support model |  | 5d | 2025-02-10 | 2025-02-14 |  | 2025-02-10 | 2025-02-14 | 0d |  |  | 744d |  | finish no earlier than 2025-02-14 |  |  |  | Business & Operation Readiness | 5.31 |  |  | 75.33 | Green | GREEN |
| 2639 | 1.9.2.1.1.3 | Confirm SA Training completed |  | 10d | 2025-02-10 | 2025-02-21 |  | 2025-02-10 | 2025-02-21 | 0d |  |  | 739d |  | finish no earlier than 2025-02-21 |  |  |  | Business & Operation Readiness | 5.31 |  |  | 75.33 | Green | GREEN |
| 2640 | 1.9.2.1.1.4 | Participant Engagement / Communications |  | 15d | 2025-02-10 | 2025-02-28 |  | 2025-02-10 | 2025-02-28 | 0d |  |  | 734d |  | finish no earlier than 2025-02-28 |  |  |  | Business & Operation Readiness | 5.31 |  |  | 75.33 | Green | GREEN |
| 2641 | 1.9.2.1.1.5 | Internal Communications |  | 15d | 2025-02-10 | 2025-02-28 |  | 2025-02-10 | 2025-02-28 | 0d |  |  | 734d |  | finish no earlier than 2025-02-28 |  |  |  | Business & Operation Readiness | 5.31 |  |  | 75.33 | Green | GREEN |
| 2642 | 1.9.2.1.1.6 | Validate User Access |  | 5d | 2025-02-17 | 2025-02-21 |  | 2025-02-17 | 2025-02-21 | 0d |  |  | 739d |  | finish no earlier than 2025-02-21 |  |  |  | Business & Operation Readiness | 5.31 |  |  | 82.33 | Green | GREEN |
| 2643 | 1.9.2.1.1.7 | Target Systems and Environments Ready |  | 3d | 2025-02-20 | 2025-02-24 |  | 2025-02-20 | 2025-02-24 | 0d |  |  | 738d |  | finish no earlier than 2025-02-24 |  | HELIX |  | Business & Operation Readiness | 5.31 |  |  | 85.33 | Green | GREEN |
| 2644 | 1.9.2.1.1.8 | Provide opeartional resources with LWIs |  | 5d | 2025-02-17 | 2025-02-21 |  | 2025-02-17 | 2025-02-21 | 0d |  |  | 739d |  | finish no earlier than 2025-02-21 |  |  |  | Business & Operation Readiness | 5.31 |  |  | 82.33 | Green | GREEN |
| 2645 | 1.9.2.1.1.9 | Business Readiness Governance Approval |  | 3d | 2025-02-17 | 2025-02-19 |  | 2025-02-17 | 2025-02-19 | 0d |  |  | 741d |  | finish no earlier than 2025-02-19 |  |  |  | Business & Operation Readiness | 5.31 |  |  | 82.33 | Green | GREEN |
| 2646 | 1.9.2.1.1.10 | SIT MVC Service Activation Preparation Tasks Complete | milestone | 0d | 2025-02-28 | 2025-02-28 |  | 2025-02-28 | 2025-02-28 | 0d |  |  | 144d | 0d | finish no earlier than 2025-02-28 |  |  |  | Business & Operation Readiness | 5.31 |  |  | 93.71 | Green | GREEN |
| 2647 | 1.9.2.1.2 | MHHSP Confirms SIT MVC PPs MHHS Enabled |  | 1d | 2022-10-31 | 2022-10-31 |  | 2025-04-15 | 2025-04-15 | 0d |  |  | 753d | 747d |  |  |  |  | Business & Operation Readiness | 5.28 |  |  | -757.67 | Overdue Start | GREEN |
| 2648 | 1.9.2.1.3 | **SIT MVC Service Activation Implementation** |  | 7d? | 2025-09-11 | 2025-09-19 |  | 2025-09-12 | 2025-09-22 | 0d |  |  | 6d |  |  |  |  |  | Business & Operation Readiness | 6.13 |  |  |  |  |  |
| 2649 | 1.9.2.1.3.1 | Add EFD to DIP |  | 1d | 2025-09-11 | 2025-09-11 | 1908SS, 2647, 2646 | 2025-09-12 | 2025-09-12 | 0d |  |  | 6d | 0d |  |  |  |  | Business & Operation Readiness | 6.13 |  |  | 288.33 | Green | GREEN |
| 2650 | 1.9.2.1.3.2 | DIP Promoted to Production |  | 1d? | 2025-09-12 | 2025-09-12 | 2649 | 2025-09-15 | 2025-09-15 | 0d |  |  | 6d | 0d |  |  |  |  | Business & Operation Readiness | 6.13 |  |  | 289.33 | Green | GREEN |
| 2651 | 1.9.2.1.3.3 | SIT LDSOs Create Certificates and Test Connectivity |  | 1d? | 2025-09-15 | 2025-09-15 | 2650 | 2025-09-16 | 2025-09-16 | 0d |  |  | 6d | 0d |  |  |  |  | Business & Operation Readiness | 6.13 |  |  | 292.33 | Green | GREEN |
| 2652 | 1.9.2.1.3.4 | SIT MVC S&As Create Certificates and Test Connectivity |  | 1d? | 2025-09-15 | 2025-09-15 | 2650 | 2025-09-16 | 2025-09-16 | 0d |  |  | 28d | 19d |  |  |  |  | Business & Operation Readiness | 6.13 |  |  | 292.33 | Green | GREEN |
| 2653 | 1.9.2.1.3.5 | Create M16 in Customer Solution |  | 2d | 2025-09-15 | 2025-09-16 | 2650 | 2025-09-16 | 2025-09-17 | 0d |  |  | 6d | 0d | finish no earlier than 2025-03-07 |  |  |  | Business & Operation Readiness | 6.13 |  |  | 292.33 | Green | GREEN |
| 2654 | 1.9.2.1.3.6 | Publish ISD |  | 2d | 2025-09-17 | 2025-09-18 | 2653 | 2025-09-18 | 2025-09-19 | 0d |  |  | 6d | 0d | finish no earlier than 2025-03-07 |  |  |  | Business & Operation Readiness | 6.13 |  |  | 294.33 | Green | GREEN |
| 2655 | 1.9.2.1.3.7 | SIT LDSOs to update systems with ISD |  | 1d? | 2025-09-19 | 2025-09-19 | 2654 | 2025-09-22 | 2025-09-22 | 0d |  |  | 10d | 1d |  |  |  |  | Business & Operation Readiness | 6.13 |  |  | 296.33 | Green | GREEN |
| 2656 | 1.9.2.1.3.8 | SIT MVC S&As to update systems with ISD |  | 1d? | 2025-09-19 | 2025-09-19 | 2654 | 2025-09-22 | 2025-09-22 | 0d |  |  | 24d | 15d |  |  |  |  | Business & Operation Readiness | 6.13 |  |  | 296.33 | Green | GREEN |
| 2657 | 1.9.2.1.3.9 | SIT MVC Service Activation Implementation Complete | milestone | 0d | 2025-09-18 | 2025-09-18 | 2654 | 2025-09-19 | 2025-09-19 | 0d |  |  | 6d | 0d | finish no earlier than 2025-03-07 |  |  |  | Business & Operation Readiness | 6.13 |  |  | 295.71 | Green | GREEN |

Notes:
- 2632: 10/5 - Detail to be added when available
- 2633: 10/5 - Detail to be added when available
- 2634: 8/7/24 - Likely Servce action will be on a pp by pp basis
- 2647: 22/11/24 - For M11 need MCC enabled - need confirmation suppliers agree to being mhhs enabled
- 2648: 21/11/24 - Dates shifted due to PAB date corrections.
- 2649: 21/11/24 - Dates shifted due to PAB date corrections.
- 2650: 21/11/24 - Dates shifted due to PAB date corrections.
- 2651: 21/11/24 - Dates shifted due to PAB date corrections.
- 2652: 21/11/24 - Dates shifted due to PAB date corrections.
- 2653: 18/09/24 - This milestone is consistent with the Service Activation Verison 2.0 Process Map.

| ID | WBS | Task | Type | Duration | Start | Finish | Predecessors | Baseline start | Baseline finish | Baseline duration | Total slack | Free slack | Constraint | Text9 | Update Version | Task Status | Sched Status | RAG | Involved |
| --- | --- | --- | --- | --- | --- | --- | --- | --- | --- | --- | --- | --- | --- | --- | --- | --- | --- | --- | --- |
| 2658 | 1.9.2.1.4 | **SIT MVC Service Activation Implementation MDD** |  | 15d | 2025-09-19 | 2025-10-09 |  | 2025-03-06 | 2025-03-25 | 0d | 575d |  |  | Business & Operation Readiness | 6.13 |  |  |  |  |
| 2659 | 1.9.2.1.4.1 | MDD Manual Load |  | 7d | 2025-09-19 | 2025-09-29 | 2654 | 2025-03-06 | 2025-03-14 | 0d | 575d | 0d | finish no earlier than 2025-03-14 | Business & Operation Readiness | 6.13 | 296.33 | Red | RED |  |
| 2660 | 1.9.2.1.4.2 | MDD Update |  | 8d | 2025-09-30 | 2025-10-09 | 2659 | 2025-03-14 | 2025-03-25 | 0d | 575d | 0d | finish no earlier than 2025-03-25 | Business & Operation Readiness | 6.13 | 307.33 | Red | RED |  |
| 2661 | 1.9.2.1.4.3 | SIT MVC Service Activation Implementation MDD Complete | milestone | 0d | 2025-10-09 | 2025-10-09 | 2660 | 2025-03-25 | 2025-03-25 | 0d | 575d |  | finish no earlier than 2025-03-25 | Business & Operation Readiness | 6.13 | 316.71 | Red | RED |  |
| 2662 | 1.9.2.1.5 | **SIT MVC Service Activation Hypercare** |  | 21d | 2025-09-11 | 2025-10-09 |  | 2025-03-03 | 2025-03-26 | 0d | 575d |  |  | Business & Operation Readiness | 6.13 |  |  |  |  |
| 2663 | 1.9.2.1.5.1 | Service & Process Monitoring |  | 18d | 2025-09-11 | 2025-10-06 | 2649SS | 2025-03-03 | 2025-03-26 | 0d | 578d |  | finish no earlier than 2025-03-26 | Business & Operation Readiness | 6.13 | 288.33 | Red | RED |  |
| 2664 | 1.9.2.1.5.2 | Daily Reporting |  | 18d | 2025-09-11 | 2025-10-06 | 2649SS | 2025-03-03 | 2025-03-26 | 0d | 578d |  | finish no earlier than 2025-03-26 | Business & Operation Readiness | 6.13 | 288.33 | Red | RED |  |
| 2665 | 1.9.2.1.5.3 | Issue Management |  | 18d | 2025-09-11 | 2025-10-06 | 2649SS | 2025-03-03 | 2025-03-26 | 0d | 578d |  | finish no earlier than 2025-03-26 | Business & Operation Readiness | 6.13 | 288.33 | Red | RED |  |
| 2666 | 1.9.2.1.5.4 | SA Hypercare Close Down Activities |  | 18d | 2025-09-11 | 2025-10-06 | 2649SS | 2025-03-03 | 2025-03-26 | 0d | 575d | 0d | finish no earlier than 2025-03-26 | Business & Operation Readiness | 6.13 | 288.33 | Red | RED |  |
| 2667 | 1.9.2.1.5.5 | Handover to MHHSP |  | 3d | 2025-10-07 | 2025-10-09 | 2666 | 2025-03-21 | 2025-03-25 | 0d | 575d | 0d | finish no earlier than 2025-03-25 | Business & Operation Readiness | 6.13 | 314.33 | Red | RED | MHHSP |
| 2668 | 1.9.2.1.5.6 | SIT MVC Service Activation Hypercare Complete | milestone | 0d | 2025-10-09 | 2025-10-09 | 2667 | 2025-03-25 | 2025-03-25 | 0d | 575d |  | finish no earlier than 2025-03-25 | Business & Operation Readiness | 6.13 | 316.71 | Red | RED |  |
| 2669 | 1.9.2.2 | **SIT Non-MVC** |  | 841d? | 2022-10-31 | 2026-01-19 |  | 2022-10-31 | 2026-01-01 | 0d | 503d |  |  | Business & Operation Readiness | 6.13 | -650.67 | Overdue Start | RED |  |
| 2670 | 1.9.2.2.1 | **SIT Non-MVC Service Activation Preparation Tasks** |  | 610d | 2022-10-31 | 2025-02-28 |  | 2022-10-31 | 2022-10-31 | 0d | 734d |  |  | Business & Operation Readiness | 6.13 | -651.67 | Overdue Start | RED |  |
| 2671 | 1.9.2.2.1.1 | Helix Preparatory Activities Complete | milestone | 0d | 2025-02-28 | 2025-02-28 | 2646 | 2022-10-31 | 2022-10-31 | 0d | 734d |  |  | Business & Operation Readiness | 6.13 | 93.71 | Red | RED |  |
| 2672 | 1.9.2.2.1.2 | MHHSP Confirms SIT Non-MVC PPs MHHS Enabled |  | 1d | 2022-10-31 | 2022-10-31 |  | 2022-10-31 | 2022-10-31 | 0d | 847d | 739d |  | Business & Operation Readiness | 6.13 | -757.67 | Overdue Start | RED |  |
| 2673 | 1.9.2.2.2 | **SIT Non-MVC Service Activation Implementation** |  | 7d? | 2025-12-19 | 2025-12-29 |  | 2025-12-23 | 2026-01-01 | 0d | 29d |  |  | Business & Operation Readiness | 5.31 |  |  |  |  |
| 2674 | 1.9.2.2.2.1 | Add EDF to DIP |  | 1d | 2025-12-19 | 2025-12-19 | 1914SS, 2672 | 2025-12-23 | 2025-12-24 | 0d | 29d | 0d | finish no earlier than 2025-06-04 | Business & Operation Readiness | 5.31 | 387.33 | Green | GREEN |  |
| 2675 | 1.9.2.2.2.2 | DIP Promoted to Production |  | 1d | 2025-12-22 | 2025-12-22 | 2674 | 2025-12-25 | 2025-12-26 | 0d | 29d | 0d | finish no earlier than 2025-06-05 | Business & Operation Readiness | 6.13 | 390.33 | Green | GREEN |  |
| 2676 | 1.9.2.2.2.3 | SIT non-MVC S&As Create Certificates and Test Connectivity |  | 1d? | 2025-12-23 | 2025-12-23 | 2675 |  |  |  | 522d |  |  |  | 6.13 | 391.33 | No BL | GREEN |  |
| 2677 | 1.9.2.2.2.4 | Create M16 in Customer Solution |  | 2d | 2025-12-23 | 2025-12-24 | 2675 | 2025-12-29 | 2025-12-30 | 0d | 29d | 0d | finish no earlier than 2025-06-06 | Business & Operation Readiness | 6.13 | 391.33 | Green | GREEN |  |
| 2678 | 1.9.2.2.2.5 | Publish ISD |  | 2d | 2025-12-25 | 2025-12-26 | 2677 | 2025-12-31 | 2026-01-01 | 0d | 29d | 0d | finish no earlier than 2025-06-06 | Business & Operation Readiness | 6.13 | 393.33 | Green | GREEN |  |
| 2679 | 1.9.2.2.2.6 | SIT non-MVC S&As to update systems with ISD |  | 1d? | 2025-12-29 | 2025-12-29 | 2678 |  |  |  | 518d |  |  |  | 6.13 | 397.33 | No BL | GREEN |  |
| 2680 | 1.9.2.2.2.7 | SIT Non-MVC Service Activation Implementation Complete | milestone | 0d | 2025-12-26 | 2025-12-26 | 2678 | 2026-01-01 | 2026-01-01 | 0d | 29d | 0d | finish no earlier than 2025-06-06 | Business & Operation Readiness | 6.13 | 394.71 | Green | GREEN |  |
| 2681 | 1.9.2.2.3 | **SIT Non-MVC Service Activation Implementation MDD** |  | 15d | 2025-12-29 | 2026-01-16 |  | 2025-06-05 | 2025-06-24 | 0d | 504d |  |  | Business & Operation Readiness | 6.13 |  |  |  |  |
| 2682 | 1.9.2.2.3.1 | MDD Manual Load |  | 7d | 2025-12-29 | 2026-01-06 | 2678 | 2025-06-05 | 2025-06-13 | 0d | 504d | 0d | finish no earlier than 2025-06-13 | Business & Operation Readiness | 6.13 | 397.33 | Red | RED |  |
| 2683 | 1.9.2.2.3.2 | MDD Update |  | 8d | 2026-01-07 | 2026-01-16 | 2682 | 2025-06-13 | 2025-06-24 | 0d | 504d | 0d | finish no earlier than 2025-06-24 | Business & Operation Readiness | 6.13 | 406.33 | Red | RED |  |
| 2684 | 1.9.2.2.3.3 | SIT Non-MVC Service Activation Implementation MDD Complete | milestone | 0d | 2026-01-16 | 2026-01-16 | 2683 | 2025-06-24 | 2025-06-24 | 0d | 504d |  | finish no earlier than 2025-06-24 | Business & Operation Readiness | 6.13 | 415.71 | Red | RED |  |

Notes:
- 2659: 22/11/24 - Dependency added and date shifted.
- 2660: 22/11/24 - Dependency added and date shifted.
- 2661: 22/11/24 - Dependency added and date shifted.
- 2663: 22/11/24 - Dependency added and date shifted.
- 2664: 22/11/24 - Dependency added and date shifted.
- 2665: 22/11/24 - Dependency added and date shifted.
- 2666: 22/11/24 - Dependency added and date shifted.
- 2667: 22/11/24 - Dependency added and date shifted. / Action: 12/8/24: Why is ths a dep into us?
- 2668: 22/11/24 - Dependency added and date shifted.
- 2669: 22/11/24 - Dependency added and date shifted.
- 2671: Action: 12/8/24: Emailed helix to clarify what needs to go in the prep section and if hypercare is required
- 2672: 22/11/24 - Confirm Predecessors
- 2675: 22/11/24 - Dependency added and date shifted.
- 2676: 22/11/24 - Dependency added and date shifted.
- 2677: 22/11/24 - Dependency added and date shifted.
- 2678: 22/11/24 - Dependency added and date shifted.
- 2679: 22/11/24 - Dependency added and date shifted.
- 2680: 22/11/24 - Dependency added and date shifted.
- 2682: 22/11/24 - Dependency added and date shifted.
- 2683: 22/11/24 - Dependency added and date shifted.
- 2684: 22/11/24 - Dependency added and date shifted.

| ID | WBS | Task | Type | Duration | Start | Finish | Predecessors | Baseline start | Baseline finish | Baseline duration | Total slack | Free slack | Constraint | Text9 | Update Version | Task Status | Sched Status | RAG | Involved |
| --- | --- | --- | --- | --- | --- | --- | --- | --- | --- | --- | --- | --- | --- | --- | --- | --- | --- | --- | --- |
| 2685 | 1.9.2.2.4 | **Non-SIT MVC Service Activation Hypercare** |  | 22d | 2025-12-19 | 2026-01-19 |  | 2025-06-02 | 2025-06-26 | 0d | 503d |  |  | Business & Operation Readiness | 6.13 |  |  |  |  |
| 2686 | 1.9.2.2.4.1 | Service& Process Monitoring |  | 18d | 2025-12-19 | 2026-01-13 | 2674SS | 2025-06-02 | 2025-06-25 | 0d | 507d |  | finish no earlier than 2025-06-25 | Business & Operation Readiness | 6.13 | 387.33 | Red | RED |  |
| 2687 | 1.9.2.2.4.2 | Daily Reporting |  | 18d | 2025-12-19 | 2026-01-13 | 2674SS | 2025-06-02 | 2025-06-25 | 0d | 507d |  | finish no earlier than 2025-06-25 | Business & Operation Readiness | 6.13 | 387.33 | Red | RED |  |
| 2688 | 1.9.2.2.4.3 | Issue Management |  | 18d | 2025-12-19 | 2026-01-13 | 2674SS | 2025-06-02 | 2025-06-25 | 0d | 507d |  | finish no earlier than 2025-06-25 | Business & Operation Readiness | 6.13 | 387.33 | Red | RED |  |
| 2689 | 1.9.2.2.4.4 | SA Hypercare Close Down Activities |  | 18d | 2025-12-19 | 2026-01-13 | 2674SS | 2025-06-02 | 2025-06-25 | 0d | 503d | 0d | finish no earlier than 2025-06-25 | Business & Operation Readiness | 6.13 | 387.33 | Red | RED |  |
| 2690 | 1.9.2.2.4.5 | Handover to MHHSP |  | 4d | 2026-01-14 | 2026-01-19 | 2689 | 2025-06-23 | 2025-06-26 | 0d | 503d | 0d | finish no earlier than 2025-06-26 | Business & Operation Readiness | 6.13 | 413.33 | Red | RED | MHHSP |
| 2691 | 1.9.2.2.4.6 | Non-SIT MVC Service Activation Hypercare Complete (M) | milestone | 0d | 2026-01-19 | 2026-01-19 | 2690 | 2025-06-25 | 2025-06-25 | 0d | 503d |  | finish no earlier than 2025-06-25 | Business & Operation Readiness | 6.13 | 418.71 | Red | RED |  |
| 2692 | 1.9.2.3 | **Wave 1** |  | 924d | 2022-10-31 | 2026-05-14 |  | 2022-10-31 | 2026-05-14 | 0d | 420d |  |  | Business & Operation Readiness | 5.31 | -650.67 | Overdue Start | RED |  |
| 2693 | 1.9.2.3.1 | **SIT Non-MVC Service Activation Preparation Tasks** |  | 924d | 2022-10-31 | 2026-05-14 |  | 2022-10-31 | 2026-05-14 | 0d | 420d |  |  | Business & Operation Readiness | 5.31 | -651.67 | Overdue Start | RED |  |
| 2694 | 1.9.2.3.1.1 | Helix Preparatory Activities Complete | milestone | 0d | 2022-10-31 | 2022-10-31 |  | 2022-10-31 | 2022-10-31 | 0d | 1344d |  |  | Business & Operation Readiness | 5.29 | -757.67 | Overdue Start | RED |  |
| 2695 | 1.9.2.3.1.2 | MHHSP Confirms Wave 1 PPs MHHS Enabled |  | 1d | 2022-10-31 | 2022-10-31 |  | 2022-10-31 | 2022-10-31 | 0d | 907d | 902d |  | Business & Operation Readiness | 5.28 | -757.67 | Overdue Start | RED |  |
| 2696 | 1.9.2.3.1.3 | Wave 1 Service Activation |  | 21d | 2026-04-16 | 2026-05-14 | 2137, 2695 | 2026-04-13 | 2026-05-14 | 25d | 5d | 0d |  | Business & Operation Readiness | 6.13 | 505.33 | Green | GREEN |  |
| 2697 | 1.9.2.3.2 | **Wave 1 - Service Activation Implementation** |  | 171d | 2025-09-01 | 2026-04-27 |  | 2025-09-01 | 2025-09-05 | 0d | 433d |  |  | Business & Operation Readiness | 5.31 |  |  |  |  |
| 2698 | 1.9.2.3.2.1 | MHHSP Enabled Confirmation |  | 2d | 2025-09-01 | 2025-09-02 | 2672 | 2025-09-01 | 2025-09-02 | 0d | 602d |  | finish no earlier than 2025-09-02 | Business & Operation Readiness | 5.31 | 278.33 | Green | GREEN |  |
| 2699 | 1.9.2.3.2.2 | PAB Approval |  | 2d | 2026-04-16 | 2026-04-17 | 2137 | 2025-09-01 | 2025-09-02 | 0d | 439d |  | finish no earlier than 2025-09-02 | Business & Operation Readiness | 5.31 | 505.33 | Red | RED |  |
| 2700 | 1.9.2.3.2.3 | Add EFD to DIP |  | 2d | 2026-04-16 | 2026-04-17 | 2137 | 2025-09-02 | 2025-09-03 | 0d | 422d | 0d | finish no earlier than 2025-09-03 | Business & Operation Readiness | 5.31 | 505.33 | Red | RED |  |
| 2701 | 1.9.2.3.2.4 | DIP Promoted to Production |  | 2d | 2026-04-20 | 2026-04-21 | 2700 | 2025-09-03 | 2025-09-04 | 0d | 422d | 0d | finish no earlier than 2025-09-04 | Business & Operation Readiness | 5.31 | 509.33 | Red | RED |  |
| 2702 | 1.9.2.3.2.5 | Create M16 in Customer Solution |  | 2d | 2026-04-22 | 2026-04-23 | 2701 | 2025-09-04 | 2025-09-05 | 0d | 422d | 0d | finish no earlier than 2025-09-05 | Business & Operation Readiness | 5.31 | 511.33 | Red | RED |  |
| 2703 | 1.9.2.3.2.6 | Publish ISD |  | 2d | 2026-04-24 | 2026-04-27 | 2702 | 2025-09-04 | 2025-09-05 | 0d | 422d | 0d | finish no earlier than 2025-09-05 | Business & Operation Readiness | 5.31 | 513.33 | Red | RED |  |
| 2704 | 1.9.2.3.2.7 | Wave 1 - Service Activation Implementation Complete (M) | milestone | 0d | 2026-04-27 | 2026-04-27 | 2703 | 2025-09-05 | 2025-09-05 | 0d | 433d |  | finish no earlier than 2025-09-05 | Business & Operation Readiness | 5.31 | 516.71 | Red | RED |  |
| 2705 | 1.9.2.3.3 | **Wave 1 - Service Activation Implementation MDD** |  | 11d | 2026-04-28 | 2026-05-12 |  | 2025-09-04 | 2025-09-17 | 0d | 422d |  |  | Business & Operation Readiness | 5.31 |  |  |  |  |
| 2706 | 1.9.2.3.3.1 | MDD Manual Load |  | 5d | 2026-04-28 | 2026-05-04 | 2703 | 2025-09-04 | 2025-09-10 | 0d | 422d | 0d | finish no earlier than 2025-09-10 | Business & Operation Readiness | 5.31 | 517.33 | Red | RED |  |
| 2707 | 1.9.2.3.3.2 | MDD Update |  | 6d | 2026-05-05 | 2026-05-12 | 2706 | 2025-09-10 | 2025-09-17 | 0d | 422d | 0d | finish no earlier than 2025-09-17 | Business & Operation Readiness | 5.31 | 524.33 | Red | RED |  |
| 2708 | 1.9.2.3.3.3 | Wave 1 - Service Activation Implementation MDD Complete (M) | milestone | 0d | 2026-05-12 | 2026-05-12 | 2707 | 2025-09-17 | 2025-09-17 | 0d | 422d |  | finish no earlier than 2025-09-17 | Business & Operation Readiness | 5.31 | 531.71 | Red | RED |  |

Notes:
- 2686: 22/11/24 - Dependency added and date shifted.
- 2687: 22/11/24 - Dependency added and date shifted.
- 2688: 22/11/24 - Dependency added and date shifted.
- 2689: 22/11/24 - Dependency added and date shifted.
- 2690: 22/11/24 - Dependency added and date shifted.
- 2691: 22/11/24 - Dependency added and date shifted.
- 2692: 08/07/24 - Confirm Predecessors
- 2694: Action: 12/8/24: Emailed helix to clarify what needs to go in the prep section and if hypercare is required
- 2696: 14/11/24 - Duration reduced to ensure the date remains the same despite a minor change in 2040. Expecting this duration to be further reduced.

| ID | WBS | Task | Type | Duration | Start | Finish | Predecessors | Baseline start | Baseline finish | Baseline duration | Total slack | Free slack | Constraint | Text9 | Update Version | Task Status | Sched Status | RAG | Future RAG |
| --- | --- | --- | --- | --- | --- | --- | --- | --- | --- | --- | --- | --- | --- | --- | --- | --- | --- | --- | --- |
| 2709 | 1.9.2.3.4 | **Wave 1 - Service Activation Hypercare** |  | 177d | 2025-09-01 | 2026-05-05 |  | 2022-10-31 | 2025-09-18 | 0d | 427d |  |  | Business & Operation Readiness | 5.31 |  |  |  |  |
| 2710 | 1.9.2.3.4.1 | Service& Process Monitoring |  | 14d | 2026-04-16 | 2026-05-05 | 2700SS | 2025-09-01 | 2025-09-18 | 0d | 427d |  | finish no earlier than 2025-09-18 | Business & Operation Readiness | 5.31 | 505.33 | Red | RED |  |
| 2711 | 1.9.2.3.4.2 | Daily Reporting |  | 14d | 2026-04-16 | 2026-05-05 | 2700SS | 2025-09-01 | 2025-09-18 | 0d | 427d |  | finish no earlier than 2025-09-18 | Business & Operation Readiness | 5.31 | 505.33 | Red | RED |  |
| 2712 | 1.9.2.3.4.3 | Issue Management |  | 14d | 2026-04-16 | 2026-05-05 | 2700SS | 2025-09-01 | 2025-09-18 | 0d | 427d |  | finish no earlier than 2025-09-18 | Business & Operation Readiness | 5.31 | 505.33 | Red | RED |  |
| 2713 | 1.9.2.3.4.4 | SA Hypercare Close Down Activities |  | 14d | 2025-09-01 | 2025-09-18 |  | 2025-09-01 | 2025-09-18 | 0d | 586d | 0d | finish no earlier than 2025-09-18 | Business & Operation Readiness | 5.31 | 278.33 | Green | GREEN |  |
| 2714 | 1.9.2.3.4.5 | Handover to MHHSP |  | 4d | 2025-09-19 | 2025-09-24 | 2713 | 2025-09-15 | 2025-09-18 | 0d | 586d | 0d | finish no earlier than 2025-09-18 | Business & Operation Readiness | 5.31 | 296.33 | yellow | RED |  |
| 2715 | 1.9.2.3.4.6 | Non-SIT LDSO Service Activation Hypercare Complete (M) | milestone | 0d | 2025-09-24 | 2025-09-24 | 2714 | 2022-10-31 | 2022-10-31 | 0d | 586d |  |  | Business & Operation Readiness | 5.31 | 301.71 | Red | RED | Dates to be confirmed |
| 2716 | 1.9.2.4 | **Wave 2** |  | 958d | 2022-10-31 | 2026-07-01 |  | 2022-10-31 | 2026-06-30 | 0d | 386d |  |  | Business & Operation Readiness | 5.31 | -650.67 | Overdue Start | RED |  |
| 2717 | 1.9.2.4.1 | **SIT Non-MVC Service Activation Preparation Tasks** |  | 958d | 2022-10-31 | 2026-07-01 |  | 2022-10-31 | 2026-06-30 | 0d | 386d |  |  | Business & Operation Readiness | 5.31 | -651.67 | Overdue Start | RED |  |
| 2718 | 1.9.2.4.1.1 | Helix Preparatory Activities Complete | milestone | 0d | 2022-10-31 | 2022-10-31 |  | 2022-10-31 | 2022-10-31 | 0d | 1344d |  |  | Business & Operation Readiness | 5.29 | -757.67 | Overdue Start | RED |  |
| 2719 | 1.9.2.4.1.2 | MHHSP Confirms Wave 2 PPs MHHS Enabled |  | 1d | 2022-10-31 | 2022-10-31 |  | 2022-10-31 | 2022-10-31 | 0d | 938d | 933d |  | Business & Operation Readiness | 5.28 | -757.67 | Overdue Start | RED |  |
| 2720 | 1.9.2.4.1.3 | Wave 2 Service Activation |  | 24d | 2026-05-29 | 2026-07-01 | 2167, 2719 | 2026-05-28 | 2026-06-30 | 25d | 5d | 0d |  | Business & Operation Readiness | 5.24 | 548.33 | yellow | RED |  |
| 2721 | 1.9.2.4.2 | **Wave 2 - Service Activation Implementation** |  | 151d | 2025-11-03 | 2026-06-01 |  | 2025-11-03 | 2025-11-07 | 0d | 408d |  |  | Business & Operation Readiness | 5.31 |  |  |  |  |
| 2722 | 1.9.2.4.2.1 | MHHSP Enabled Confirmation |  | 2d | 2025-11-03 | 2025-11-04 |  | 2025-11-03 | 2025-11-04 | 0d | 557d |  | finish no earlier than 2025-11-04 | Business & Operation Readiness | 5.31 | 341.33 | Green | GREEN |  |
| 2723 | 1.9.2.4.2.2 | PAB Approval |  | 2d | 2026-05-29 | 2026-06-01 | 2167 | 2025-11-03 | 2025-11-04 | 0d | 408d |  | finish no earlier than 2025-11-04 | Business & Operation Readiness | 5.31 | 548.33 | Red | RED |  |
| 2724 | 1.9.2.4.2.3 | Add EFD to DIP |  | 2d | 2025-11-04 | 2025-11-05 |  | 2025-11-04 | 2025-11-05 | 0d | 556d |  | finish no earlier than 2025-11-05 | Business & Operation Readiness | 5.31 | 342.33 | Green | GREEN |  |
| 2725 | 1.9.2.4.2.4 | DIP Promoted to Production |  | 2d | 2025-11-05 | 2025-11-06 |  | 2025-11-05 | 2025-11-06 | 0d | 555d |  | finish no earlier than 2025-11-06 | Business & Operation Readiness | 5.31 | 343.33 | Green | GREEN |  |
| 2726 | 1.9.2.4.2.5 | Create M16 in Customer Solution |  | 2d | 2025-11-06 | 2025-11-07 |  | 2025-11-06 | 2025-11-07 | 0d | 554d |  | finish no earlier than 2025-11-07 | Business & Operation Readiness | 5.31 | 344.33 | Green | GREEN |  |
| 2727 | 1.9.2.4.2.6 | Publish ISD |  | 2d | 2025-11-06 | 2025-11-07 |  | 2025-11-06 | 2025-11-07 | 0d | 554d |  | finish no earlier than 2025-11-07 | Business & Operation Readiness | 5.31 | 344.33 | Green | GREEN |  |
| 2728 | 1.9.2.4.2.7 | Wave 2 - Service Activation Implementation Complete (M) | milestone | 0d | 2025-11-07 | 2025-11-07 |  | 2025-11-07 | 2025-11-07 | 0d | 554d |  | finish no earlier than 2025-11-07 | Business & Operation Readiness | 5.31 | 345.71 | Green | GREEN |  |
| 2729 | 1.9.2.4.3 | **Wave 2 - Service Activation Implementation MDD** |  | 10d | 2025-11-06 | 2025-11-19 |  | 2025-11-06 | 2025-11-19 | 0d | 546d |  |  | Business & Operation Readiness | 5.31 |  |  |  |  |
| 2730 | 1.9.2.4.3.1 | MDD Manual Load |  | 5d | 2025-11-06 | 2025-11-12 |  | 2025-11-06 | 2025-11-12 | 0d | 551d |  | finish no earlier than 2025-11-12 | Business & Operation Readiness | 5.31 | 344.33 | Green | GREEN |  |
| 2731 | 1.9.2.4.3.2 | MDD Update |  | 6d | 2025-11-12 | 2025-11-19 |  | 2025-11-12 | 2025-11-19 | 0d | 546d |  | finish no earlier than 2025-11-19 | Business & Operation Readiness | 5.31 | 350.33 | Green | GREEN |  |
| 2732 | 1.9.2.4.3.3 | Wave 2 - Service Activation Implementation MDD Complete (M) | milestone | 0d | 2025-11-19 | 2025-11-19 |  | 2025-11-19 | 2025-11-19 | 0d | 546d |  | finish no earlier than 2025-11-19 | Business & Operation Readiness | 5.31 | 357.71 | Green | GREEN |  |

Notes:
- 2716: 08/07/24 - Confirm Predecessors
- 2718: Action: 12/8/24: Emailed helix to clarify what needs to go in the prep section and if hypercare is required

| ID | WBS | Task | Type | Duration | Start | Finish | Predecessors | Baseline start | Baseline finish | Baseline duration | Total slack | Free slack | Constraint | Text9 | Update Version | Task Status | Sched Status | RAG | Involved | Future RAG |
| --- | --- | --- | --- | --- | --- | --- | --- | --- | --- | --- | --- | --- | --- | --- | --- | --- | --- | --- | --- | --- |
| 2733 | 1.9.2.4.4 | **Wave 2 - Service Activation Hypercare** |  | 14d | 2025-11-03 | 2025-11-20 |  | 2025-11-03 | 2025-11-20 | 0d | 545d |  |  | Business & Operation Readiness | 5.31 |  |  |  |  |  |
| 2734 | 1.9.2.4.4.1 | Service& Process Monitoring |  | 14d | 2025-11-03 | 2025-11-20 |  | 2025-11-03 | 2025-11-20 | 0d | 545d |  | finish no earlier than 2025-11-20 | Business & Operation Readiness | 5.31 | 341.33 | Green | GREEN |  |  |
| 2735 | 1.9.2.4.4.2 | Daily Reporting |  | 14d | 2025-11-03 | 2025-11-20 |  | 2025-11-03 | 2025-11-20 | 0d | 545d |  | finish no earlier than 2025-11-20 | Business & Operation Readiness | 5.31 | 341.33 | Green | GREEN |  |  |
| 2736 | 1.9.2.4.4.3 | Issue Management |  | 14d | 2025-11-03 | 2025-11-20 |  | 2025-11-03 | 2025-11-20 | 0d | 545d |  | finish no earlier than 2025-11-20 | Business & Operation Readiness | 5.31 | 341.33 | Green | GREEN |  |  |
| 2737 | 1.9.2.4.4.4 | SA Hypercare Close Down Activities |  | 14d | 2025-11-03 | 2025-11-20 |  | 2025-11-03 | 2025-11-20 | 0d | 545d |  | finish no earlier than 2025-11-20 | Business & Operation Readiness | 5.31 | 341.33 | Green | GREEN |  |  |
| 2738 | 1.9.2.4.4.5 | Handover to MHHSP |  | 4d | 2025-11-17 | 2025-11-20 |  | 2025-11-17 | 2025-11-20 | 0d | 545d |  | finish no earlier than 2025-11-20 | Business & Operation Readiness | 5.31 | 355.33 | Green | GREEN | MHHSP |  |
| 2739 | 1.9.2.4.4.6 | Wave 2 - Service Activation Hypercare Complete (M) | milestone | 0d | 2025-11-19 | 2025-11-19 |  | 2025-11-19 | 2025-11-19 | 0d | 546d |  | finish no earlier than 2025-11-19 | Business & Operation Readiness | 5.31 | 357.71 | Green | GREEN |  |  |
| 2740 | 1.9.2.5 | **Wave 3** |  | 989d | 2022-10-31 | 2026-08-13 |  | 2022-10-31 | 2026-08-26 | 0d | 355d |  |  | Business & Operation Readiness | 5.31 | -650.67 | Overdue Start | RED |  |  |
| 2741 | 1.9.2.5.1 | **SIT Non-MVC Service Activation Preparation Tasks** |  | 989d | 2022-10-31 | 2026-08-13 |  | 2022-10-31 | 2026-08-26 | 0d | 355d |  |  | Business & Operation Readiness | 5.31 | -651.67 | Overdue Start | RED |  |  |
| 2742 | 1.9.2.5.1.1 | Helix Preparatory Activities Complete | milestone | 0d | 2022-10-31 | 2022-10-31 |  | 2022-10-31 | 2022-10-31 | 0d | 1344d |  |  | Business & Operation Readiness | 5.29 | -757.67 | Overdue Start | RED |  |  |
| 2743 | 1.9.2.5.1.2 | MHHSP Confirms Wave 3 PPs MHHS Enabled |  | 1d | 2022-10-31 | 2022-10-31 |  | 2022-10-31 | 2022-10-31 | 0d | 987d | 978d |  | Business & Operation Readiness | 5.28 | -757.67 | Overdue Start | RED |  |  |
| 2744 | 1.9.2.5.1.3 | Wave 3 Service Activation |  | 10d | 2026-07-31 | 2026-08-13 | 2197, 2743 | 2026-07-24 | 2026-08-26 | 25d | 9d | 0d |  | Business & Operation Readiness | 5.24 | 611.33 | Green | GREEN |  |  |
| 2745 | 1.9.2.5.2 | **Wave 3 - Service Activation Implementation** |  | 161d | 2025-12-22 | 2026-08-03 |  | 2025-12-22 | 2025-12-30 | 0d | 363d |  |  | Business & Operation Readiness | 5.31 |  |  |  |  |  |
| 2746 | 1.9.2.5.2.1 | MHHSP Enabled Confirmation |  | 2d | 2025-12-22 | 2025-12-23 |  | 2025-12-22 | 2025-12-23 | 0d | 522d |  | finish no earlier than 2025-12-23 | Business & Operation Readiness | 5.31 | 390.33 | Green | GREEN |  |  |
| 2747 | 1.9.2.5.2.2 | PAB Approval |  | 2d | 2026-07-31 | 2026-08-03 | 2197 | 2025-12-22 | 2025-12-23 | 0d | 363d |  | finish no earlier than 2025-12-23 | Business & Operation Readiness | 5.31 | 611.33 | Red | RED |  |  |
| 2748 | 1.9.2.5.2.3 | Add EFD to DIP |  | 2d | 2025-12-23 | 2025-12-24 |  | 2025-12-23 | 2025-12-24 | 0d | 521d |  | finish no earlier than 2025-12-24 | Business & Operation Readiness | 5.31 | 391.33 | Green | GREEN |  |  |
| 2749 | 1.9.2.5.2.4 | DIP Promoted to Production |  | 2d | 2025-12-29 | 2025-12-30 |  | 2025-12-29 | 2025-12-30 | 0d | 517d |  | finish no earlier than 2025-12-30 | Business & Operation Readiness | 5.31 | 397.33 | Green | GREEN |  |  |
| 2750 | 1.9.2.5.2.5 | Create M16 in Customer Solution |  | 2d | 2025-12-29 | 2025-12-30 |  | 2025-12-29 | 2025-12-30 | 0d | 517d |  | finish no earlier than 2025-12-30 | Business & Operation Readiness | 5.31 | 397.33 | Green | GREEN |  |  |
| 2751 | 1.9.2.5.2.6 | Publish ISD |  | 2d | 2025-12-29 | 2025-12-30 |  | 2025-12-29 | 2025-12-30 | 0d | 517d |  | finish no earlier than 2025-12-30 | Business & Operation Readiness | 5.31 | 397.33 | Green | GREEN |  |  |
| 2752 | 1.9.2.5.2.7 | Wave 3 - Service Activation Implementation Complete (M) | milestone | 0d | 2025-12-30 | 2025-12-30 |  | 2025-12-30 | 2025-12-30 | 0d | 517d |  | finish no earlier than 2025-12-30 | Business & Operation Readiness | 5.31 | 398.71 | Green | GREEN |  |  |
| 2753 | 1.9.2.5.3 | **Wave 3 - Service Activation Implementation MDD** |  | 839d | 2022-10-31 | 2026-01-15 |  | 2022-10-31 | 2026-01-15 | 0d | 505d |  |  | Business & Operation Readiness | 5.31 |  |  |  |  |  |
| 2754 | 1.9.2.5.3.1 | MDD Manual Load |  | 7d | 2025-12-29 | 2026-01-06 |  | 2025-12-29 | 2026-01-06 | 0d | 512d |  | finish no earlier than 2026-01-06 | Business & Operation Readiness | 5.31 | 397.33 | Green | GREEN |  |  |
| 2755 | 1.9.2.5.3.2 | MDD Update |  | 269d | 2025-01-06 | 2026-01-15 |  | 2025-01-06 | 2026-01-15 | 0d | 505d |  | finish no earlier than 2026-01-15 | Business & Operation Readiness | 5.31 | 40.33 | Green | GREEN |  |  |
| 2756 | 1.9.2.5.3.3 | Wave 3 - Service Activation Implementation MDD Complete (M) | milestone | 0d | 2022-10-31 | 2022-10-31 |  | 2022-10-31 | 2022-10-31 | 0d | 1344d |  |  | Business & Operation Readiness | 5.31 | -757.67 | Overdue Start | RED |  | Dates to be confirmed |

Notes:
- 2741: 08/07/24 - Confirm Predecessors
- 2742: Action: 12/8/24: Emailed helix to clarify what needs to go in the prep section and if hypercare is required

| ID | WBS | Task | Type | Duration | Start | Finish | Predecessors | Baseline start | Baseline finish | Baseline duration | Total slack | Constraint | Text9 | Update Version | Task Status | Sched Status | RAG | Involved | Future RAG |
| --- | --- | --- | --- | --- | --- | --- | --- | --- | --- | --- | --- | --- | --- | --- | --- | --- | --- | --- | --- |
| 2757 | 1.9.2.5.4 | **Wave 3 - Service Activation Hypercare** |  | 840d | 2022-10-31 | 2026-01-16 |  | 2022-10-31 | 2026-01-16 | 0d | 504d |  | Business & Operation Readiness | 5.31 |  |  |  |  |  |
| 2758 | 1.9.2.5.4.1 | Service& Process Monitoring |  | 20d | 2025-12-22 | 2026-01-16 |  | 2025-12-22 | 2026-01-16 | 0d | 504d | finish no earlier than 2026-01-16 | Business & Operation Readiness | 5.31 | 390.33 | Green | GREEN |  |  |
| 2759 | 1.9.2.5.4.2 | Daily Reporting |  | 20d | 2025-12-22 | 2026-01-16 |  | 2025-12-22 | 2026-01-16 | 0d | 504d | finish no earlier than 2026-01-16 | Business & Operation Readiness | 5.31 | 390.33 | Green | GREEN |  |  |
| 2760 | 1.9.2.5.4.3 | Issue Management |  | 20d | 2025-12-22 | 2026-01-16 |  | 2025-12-22 | 2026-01-16 | 0d | 504d | finish no earlier than 2026-01-16 | Business & Operation Readiness | 5.31 | 390.33 | Green | GREEN |  |  |
| 2761 | 1.9.2.5.4.4 | SA Hypercare Close Down Activities |  | 20d | 2025-12-22 | 2026-01-16 |  | 2025-12-22 | 2026-01-16 | 0d | 504d | finish no earlier than 2026-01-16 | Business & Operation Readiness | 5.31 | 390.33 | Green | GREEN |  |  |
| 2762 | 1.9.2.5.4.5 | Handover to MHHSP |  | 4d | 2026-01-12 | 2026-01-15 |  | 2026-01-12 | 2026-01-15 | 0d | 505d | finish no earlier than 2026-01-15 | Business & Operation Readiness | 5.31 | 411.33 | Green | GREEN | MHHSP |  |
| 2763 | 1.9.2.5.4.6 | Wave 3 Service Activation Hypercare Complete (M) | milestone | 0d | 2022-10-31 | 2022-10-31 |  | 2022-10-31 | 2022-10-31 | 0d | 1344d |  | Business & Operation Readiness | 5.31 | -757.67 | Overdue Start | RED |  | Date to be confirmed |
| 2764 | 1.9.2.6 | **Wave 4** |  | 1043d | 2022-10-31 | 2026-10-28 |  | 2022-10-31 | 2026-10-22 | 0d | 301d |  | Business & Operation Readiness | 5.31 | -650.67 | Overdue Start | RED |  |  |
| 2765 | 1.9.2.6.1 | **SIT Non-MVC Service Activation Preparation Tasks** |  | 1043d | 2022-10-31 | 2026-10-28 |  | 2022-10-31 | 2026-10-22 | 0d | 301d |  | Business & Operation Readiness | 5.31 | -651.67 | Overdue Start | RED |  |  |
| 2766 | 1.9.2.6.1.1 | Helix Preparatory Activities Complete | milestone | 0d | 2022-10-31 | 2022-10-31 |  | 2022-10-31 | 2022-10-31 | 0d | 1344d |  | Business & Operation Readiness | 5.29 | -757.67 | Overdue Start | RED |  |  |
| 2767 | 1.9.2.6.1.2 | MHHSP Confirms Wave 4 PPs MHHS Enabled |  | 1d | 2022-10-31 | 2022-10-31 |  | 2022-10-31 | 2022-10-31 | 0d | 1018d |  | Business & Operation Readiness | 5.28 | -757.67 | Overdue Start | RED |  |  |
| 2768 | 1.9.2.6.1.3 | Wave 4 Service Activation |  | 24d | 2026-09-25 | 2026-10-28 | 2227, 2767 | 2026-09-21 | 2026-10-22 | 25d | 0d |  | Business & Operation Readiness | 5.24 | 667.33 | yellow | RED |  |  |
| 2769 | 1.9.2.6.2 | **Wave 4 - Service Activation Implementation** |  | 150d | 2026-03-02 | 2026-09-25 |  | 2025-03-03 | 2026-03-06 | 0d | 324d |  | Business & Operation Readiness | 5.31 |  |  |  |  |  |
| 2770 | 1.9.2.6.2.1 | MHHSP Enabled Confirmation |  | 2d | 2026-03-02 | 2026-03-03 |  | 2026-03-02 | 2026-03-03 | 0d | 472d | finish no earlier than 2026-03-03 | Business & Operation Readiness | 5.31 | 460.33 | Green | GREEN |  |  |
| 2771 | 1.9.2.6.2.2 | PAB Approval |  | 1d | 2026-09-25 | 2026-09-25 | 2227 | 2025-03-03 | 2025-03-03 | 0d | 324d | finish no earlier than 2025-03-03 | Business & Operation Readiness | 5.31 | 667.33 | Red | RED |  |  |
| 2772 | 1.9.2.6.2.3 | Add EFD to DIP |  | 2d | 2026-03-03 | 2026-03-04 |  | 2026-03-03 | 2026-03-04 | 0d | 471d | finish no earlier than 2026-03-04 | Business & Operation Readiness | 5.31 | 461.33 | Green | GREEN |  |  |
| 2773 | 1.9.2.6.2.4 | DIP Promoted to Production |  | 2d | 2026-03-04 | 2026-03-05 |  | 2026-03-04 | 2026-03-05 | 0d | 470d | finish no earlier than 2026-03-05 | Business & Operation Readiness | 5.31 | 462.33 | Green | GREEN |  |  |
| 2774 | 1.9.2.6.2.5 | Create M16 in Customer Solution |  | 2d | 2026-03-05 | 2026-03-06 |  | 2026-03-05 | 2026-03-06 | 0d | 469d | finish no earlier than 2026-03-06 | Business & Operation Readiness | 5.31 | 463.33 | Green | GREEN |  |  |
| 2775 | 1.9.2.6.2.6 | Publish ISD |  | 2d | 2026-03-05 | 2026-03-06 |  | 2026-03-05 | 2026-03-06 | 0d | 469d | finish no earlier than 2026-03-06 | Business & Operation Readiness | 5.31 | 463.33 | Green | GREEN |  |  |
| 2776 | 1.9.2.6.2.7 | Wave 4 - Service Activation Implementation Complete (M) | milestone | 0d | 2026-03-06 | 2026-03-06 |  | 2026-03-06 | 2026-03-06 | 0d | 469d | finish no earlier than 2026-03-06 | Business & Operation Readiness | 5.31 | 464.71 | Green | GREEN |  |  |
| 2777 | 1.9.2.6.3 | **Wave 4 - Service Activation Implementation MDD** |  | 15d | 2026-03-06 | 2026-03-26 |  | 2026-03-06 | 2026-03-26 | 0d | 455d |  | Business & Operation Readiness | 5.31 |  |  |  |  |  |
| 2778 | 1.9.2.6.3.1 | MDD Manual Load |  | 7d | 2026-03-06 | 2026-03-16 |  | 2026-03-06 | 2026-03-16 | 0d | 463d | finish no earlier than 2026-03-16 | Business & Operation Readiness | 5.31 | 464.33 | Green | GREEN |  |  |
| 2779 | 1.9.2.6.3.2 | MDD Update |  | 9d | 2026-03-16 | 2026-03-26 |  | 2026-03-16 | 2026-03-26 | 0d | 455d | finish no earlier than 2026-03-26 | Business & Operation Readiness | 5.31 | 474.33 | Green | GREEN |  |  |
| 2780 | 1.9.2.6.3.3 | Wave 4 - Service Activation Implementation MDD Complete | milestone | 0d | 2026-03-25 | 2026-03-25 |  | 2026-03-25 | 2026-03-25 | 0d | 456d | finish no earlier than 2026-03-25 | Business & Operation Readiness | 5.31 | 483.71 | Green | GREEN |  |  |

Notes:
- 2764: 08/07/24 - Confirm Predecessors
- 2766: Action: 12/8/24: Emailed helix to clarify what needs to go in the prep section and if hypercare is required
- 2767: 8/7/24 - Confirm Predecessors

| ID | WBS | Task | Type | Duration | Start | Finish | Predecessors | Baseline start | Baseline finish | Baseline duration | Total slack | Free slack | Constraint | Text9 | Update Version | Task Status | Sched Status | RAG | Involved | Responsible |
| --- | --- | --- | --- | --- | --- | --- | --- | --- | --- | --- | --- | --- | --- | --- | --- | --- | --- | --- | --- | --- |
| 2781 | 1.9.2.6.4 | **Wave 4 - Service Activation Hypercare** |  | 19d | 2026-03-02 | 2026-03-26 |  | 2026-03-02 | 2026-03-26 | 0d | 455d |  |  | Business & Operation Readiness | 5.31 |  |  |  |  |  |
| 2782 | 1.9.2.6.4.1 | Service& Process Monitoring |  | 19d | 2026-03-02 | 2026-03-26 |  | 2026-03-02 | 2026-03-26 | 0d | 455d |  | finish no earlier than 2026-03-26 | Business & Operation Readiness | 5.31 | 460.33 | Green | GREEN |  |  |
| 2783 | 1.9.2.6.4.2 | Daily Reporting |  | 19d | 2026-03-02 | 2026-03-26 |  | 2026-03-02 | 2026-03-26 | 0d | 455d |  | finish no earlier than 2026-03-26 | Business & Operation Readiness | 5.31 | 460.33 | Green | GREEN |  |  |
| 2784 | 1.9.2.6.4.3 | Issue Management |  | 19d | 2026-03-02 | 2026-03-26 |  | 2026-03-02 | 2026-03-26 | 0d | 455d |  | finish no earlier than 2026-03-26 | Business & Operation Readiness | 5.31 | 460.33 | Green | GREEN |  |  |
| 2785 | 1.9.2.6.4.4 | SA Hypercare Close Down Activities |  | 19d | 2026-03-02 | 2026-03-26 |  | 2026-03-02 | 2026-03-26 | 0d | 455d |  | finish no earlier than 2026-03-26 | Business & Operation Readiness | 5.31 | 460.33 | Green | GREEN |  |  |
| 2786 | 1.9.2.6.4.5 | Handover to MHHSP |  | 4d | 2026-03-02 | 2026-03-05 |  | 2026-03-02 | 2026-03-05 | 0d | 470d |  | finish no earlier than 2026-03-05 | Business & Operation Readiness | 5.31 | 460.33 | Green | GREEN | MHHSP |  |
| 2787 | 1.9.2.6.4.6 | Wave 4 - Service Activation Hypercare Complete (M) | milestone | 0d | 2026-03-25 | 2026-03-25 |  | 2026-03-25 | 2026-03-25 | 0d | 456d |  | finish no earlier than 2026-03-25 | Business & Operation Readiness | 5.31 | 483.71 | Green | GREEN |  |  |
| 2788 | 1.9.2.7 | **Non-SIT LDSO** |  | 754d | 2022-10-31 | 2025-09-18 |  | 2022-10-31 | 2025-09-01 | 0d | 590d |  |  | Business & Operation Readiness | 5.31 | -650.67 | Overdue Start | RED |  |  |
| 2789 | 1.9.2.7.1 | **Non-SIT LDSO Service Activation Data Loading** |  | 176d | 2024-06-07 | 2025-02-07 |  | 2024-06-07 | 2025-02-07 | 0d | 749d |  |  | Business & Operation Readiness | 5.31 |  |  |  |  |  |
| 2790 | 1.9.2.7.1.1 | Define pre Non-SIT LDSO upfront activities |  | 7d | 2024-06-07 | 2024-06-17 |  | 2024-06-07 | 2024-06-17 | 0d | 918d |  | finish no earlier than 2024-06-17 | Business & Operation Readiness | 5.31 | -172.67 | Overdue Start | RED |  |  |
| 2791 | 1.9.2.7.1.2 | **Execute Non-SIT LDSO Activities** |  | 5d | 2025-02-03 | 2025-02-07 |  | 2025-02-03 | 2025-02-07 | 0d | 749d |  |  | Business & Operation Readiness | 5.31 |  |  |  |  |  |
| 2792 | 1.9.2.7.1.2.1 | Create Entity Forms in Customer Solution |  | 3d | 2025-02-03 | 2025-02-05 |  | 2025-02-03 | 2025-02-05 | 0d | 751d |  | finish no earlier than 2025-02-05 | Business & Operation Readiness | 5.31 | 68.33 | Green | GREEN |  | PMP |
| 2793 | 1.9.2.7.1.2.2 | DIP - Promote to Production Environment |  | 3d | 2025-02-03 | 2025-02-05 |  | 2025-02-03 | 2025-02-05 | 0d | 751d |  | finish no earlier than 2025-02-05 | Business & Operation Readiness | 5.31 | 68.33 | Green | GREEN |  | DIP |
| 2794 | 1.9.2.7.1.2.3 | DIP - Enable Technology capabilities for participants |  | 3d | 2025-02-03 | 2025-02-05 |  | 2025-02-03 | 2025-02-05 | 0d | 751d |  | finish no earlier than 2025-02-05 | Business & Operation Readiness | 5.31 | 68.33 | Green | GREEN |  | DIP |
| 2795 | 1.9.2.7.1.2.4 | DIP - Add EFD to DIP |  | 3d | 2025-02-03 | 2025-02-05 |  | 2025-02-03 | 2025-02-05 | 0d | 751d |  | finish no earlier than 2025-02-05 | Business & Operation Readiness | 5.31 | 68.33 | Green | GREEN |  | DIP |
| 2796 | 1.9.2.7.1.2.5 | ISD - Replicate Entity Forms from CS |  | 2d | 2025-02-06 | 2025-02-07 |  | 2025-02-06 | 2025-02-07 | 0d | 749d |  | finish no earlier than 2025-02-07 | Business & Operation Readiness | 5.31 | 71.33 | Green | GREEN |  | HELIX |
| 2797 | 1.9.2.7.1.2.6 | MDD - Load MHHS roles |  | 3d | 2025-02-03 | 2025-02-05 |  | 2025-02-03 | 2025-02-05 | 0d | 751d |  | finish no earlier than 2025-02-05 | Business & Operation Readiness | 5.31 | 68.33 | Green | GREEN |  | PMP |
| 2798 | 1.9.2.7.1.3 | Non-SIT LDSO Service Activation Data Loading Completed (M) | milestone | 0d | 2025-02-07 | 2025-02-07 |  | 2025-02-07 | 2025-02-07 | 0d | 749d |  | finish no earlier than 2025-02-07 | Business & Operation Readiness | 5.31 | 72.71 | Green | GREEN |  |  |
| 2799 | 1.9.2.7.2 | **SIT Non-MVC Service Activation Preparation Tasks** |  | 754d | 2022-10-31 | 2025-09-18 |  | 2022-10-31 | 2025-09-01 | 0d | 590d |  |  | Business & Operation Readiness | 5.31 | -651.67 | Overdue Start | RED |  |  |
| 2800 | 1.9.2.7.2.1 | Helix Preparatory Activities Complete | milestone | 0d | 2022-10-31 | 2022-10-31 |  | 2022-10-31 | 2022-10-31 | 0d | 1344d |  |  | Business & Operation Readiness | 5.29 | -757.67 | Overdue Start | RED |  |  |
| 2801 | 1.9.2.7.2.2 | MHHSP Confirms Non-SIT LDSO PPs MHHS Enabled |  | 1d | 2022-10-31 | 2022-10-31 |  | 2022-10-31 | 2022-10-31 | 0d | 756d | 747d |  | Business & Operation Readiness | 5.28 | -757.67 | Overdue Start | RED |  |  |
| 2802 | 1.9.2.7.2.3 | Non-SIT LDSO Service Activation |  | 6d | 2025-09-11 | 2025-09-18 | 2801, 1926 | 2025-08-25 | 2025-09-01 | 9d | 9d | 3d |  | Business & Operation Readiness | 6.12 | 288.33 | Red | RED |  |  |
| 2803 | 1.9.2.7.3 | **Non-SIT LDSO Service Activation Implementation** |  | 4d | 2025-02-24 | 2025-02-27 |  | 2025-02-24 | 2025-02-27 | 0d | 735d |  |  | Business & Operation Readiness | 5.31 |  |  |  |  |  |
| 2804 | 1.9.2.7.3.1 | MHHSP Enabled Confirmation |  | 2d | 2025-02-24 | 2025-02-25 |  | 2025-02-24 | 2025-02-25 | 0d | 737d |  | finish no earlier than 2025-02-25 | Business & Operation Readiness | 5.31 | 89.33 | Green | GREEN |  | MHHSP |
| 2805 | 1.9.2.7.3.2 | PAB Approval |  | 2d | 2025-02-24 | 2025-02-25 |  | 2025-02-24 | 2025-02-25 | 0d | 737d |  | finish no earlier than 2025-02-25 | Business & Operation Readiness | 5.31 | 89.33 | Green | GREEN |  | QUALF |
| 2806 | 1.9.2.7.3.3 | Add EFD to DIP |  | 2d | 2025-02-25 | 2025-02-26 |  | 2025-02-25 | 2025-02-26 | 0d | 736d |  | finish no earlier than 2025-02-26 | Business & Operation Readiness | 5.31 | 90.33 | Green | GREEN |  | DIP |
| 2807 | 1.9.2.7.3.4 | DIP Promoted to Production |  | 2d | 2025-02-26 | 2025-02-27 |  | 2025-02-26 | 2025-02-27 | 0d | 735d |  | finish no earlier than 2025-02-27 | Business & Operation Readiness | 5.31 | 91.33 | Green | GREEN |  | DIP |
| 2808 | 1.9.2.7.3.5 | Create M16 in Customer Solution |  | 2d | 2025-02-26 | 2025-02-27 |  | 2025-02-26 | 2025-02-27 | 0d | 735d |  | finish no earlier than 2025-02-27 | Business & Operation Readiness | 5.31 | 91.33 | Green | GREEN |  | PMP |
| 2809 | 1.9.2.7.3.6 | Publish ISD |  | 2d | 2025-02-26 | 2025-02-27 |  | 2025-02-26 | 2025-02-27 | 0d | 735d |  | finish no earlier than 2025-02-27 | Business & Operation Readiness | 5.31 | 91.33 | Green | GREEN |  |  |
| 2810 | 1.9.2.7.3.7 | Non-SIT LDSO Service Activation Implementation Completed (M) | milestone | 0d | 2025-02-27 | 2025-02-27 |  | 2025-02-27 | 2025-02-27 | 0d | 735d |  | finish no earlier than 2025-02-27 | Business & Operation Readiness | 5.31 | 92.71 | Green | GREEN |  |  |

Notes:
- 2800: Action: 12/8/24: Emailed helix to clarify what needs to go in the prep section and if hypercare is required
- 2801: 08/07/24 - Confirm Predecessors
- 2802: 13/11/24 - Dependency updated so that this activity is now connected to the right activity. This has resulted in the forecast slipping, but this is now the correct date, this will be baselined at Approval Group.

| ID | WBS | Task | Type | Duration | Start | Finish | Predecessors | Baseline start | Baseline finish | Baseline duration | Baseline 1 start | Baseline 1 finish | Total slack | Free slack | Constraint | Baseline cost | Text9 | Update Version | Responsible | Task Status | Sched Status | RAG | Involved | MHHS Resource Name | MHHS Programme Phase | Artefact ID | Action |
| --- | --- | --- | --- | --- | --- | --- | --- | --- | --- | --- | --- | --- | --- | --- | --- | --- | --- | --- | --- | --- | --- | --- | --- | --- | --- | --- | --- |
| 2811 | 1.9.2.7.4 | **Non-SIT LDSO Service Activation Implementation MDD** |  | 14d | 2025-02-27 | 2025-03-18 |  | 2025-02-27 | 2025-03-18 | 0d |  |  | 722d |  |  |  | Business & Operation Readiness | 5.31 |  |  |  |  |  |  |  |  |  |
| 2812 | 1.9.2.7.4.1 | MDD Manual Load |  | 7d | 2025-02-27 | 2025-03-07 |  | 2025-02-27 | 2025-03-07 | 0d |  |  | 729d |  | finish no earlier than 2025-03-07 |  | Business & Operation Readiness | 5.31 | PMP | 92.33 | Green | GREEN |  |  |  |  |  |
| 2813 | 1.9.2.7.4.2 | MDD Update |  | 8d | 2025-03-07 | 2025-03-18 |  | 2025-03-07 | 2025-03-18 | 0d |  |  | 722d |  | finish no earlier than 2025-03-18 |  | Business & Operation Readiness | 5.31 | PMP | 100.33 | Green | GREEN |  |  |  |  |  |
| 2814 | 1.9.2.7.4.3 | Non-SIT LDSO Service Activation Implementation MDD Complete (M) | milestone | 0d | 2025-03-18 | 2025-03-18 |  | 2025-03-18 | 2025-03-18 | 0d |  |  | 722d |  | finish no earlier than 2025-03-18 |  | Business & Operation Readiness | 5.31 |  | 111.71 | Green | GREEN |  |  |  |  |  |
| 2815 | 1.9.2.7.5 | **Non-SIT LDSO Service Activation Hypercare** |  | 18d | 2025-02-24 | 2025-03-19 |  | 2025-02-24 | 2025-03-19 | 0d |  |  | 721d |  |  |  | Business & Operation Readiness | 5.31 |  |  |  |  |  |  |  |  |  |
| 2816 | 1.9.2.7.5.1 | **Non-SIT LDSO Service Activation Hypercare Support** |  | 18d | 2025-02-24 | 2025-03-19 |  | 2025-02-24 | 2025-03-19 | 0d |  |  | 721d |  |  |  | Business & Operation Readiness | 5.31 |  |  |  |  |  |  |  |  |  |
| 2817 | 1.9.2.7.5.1.1 | Service& Process Monitoring |  | 18d | 2025-02-24 | 2025-03-19 |  | 2025-02-24 | 2025-03-19 | 0d |  |  | 721d |  | finish no earlier than 2025-03-19 |  | Business & Operation Readiness | 5.31 |  | 89.33 | Green | GREEN |  |  |  |  |  |
| 2818 | 1.9.2.7.5.1.2 | Daily Reporting |  | 18d | 2025-02-24 | 2025-03-19 |  | 2025-02-24 | 2025-03-19 | 0d |  |  | 721d |  | finish no earlier than 2025-03-19 |  | Business & Operation Readiness | 5.31 |  | 89.33 | Green | GREEN |  |  |  |  |  |
| 2819 | 1.9.2.7.5.1.3 | Issue Management |  | 18d | 2025-02-24 | 2025-03-19 |  | 2025-02-24 | 2025-03-19 | 0d |  |  | 721d |  | finish no earlier than 2025-03-19 |  | Business & Operation Readiness | 5.31 |  | 89.33 | Green | GREEN |  |  |  |  |  |
| 2820 | 1.9.2.7.5.1.4 | SA Hypercare Close Down Activities |  | 18d | 2025-02-24 | 2025-03-19 |  | 2025-02-24 | 2025-03-19 | 0d |  |  | 721d |  | finish no earlier than 2025-03-19 |  | Business & Operation Readiness | 5.31 |  | 89.33 | Green | GREEN |  |  |  |  |  |
| 2821 | 1.9.2.7.5.1.5 | Handover to MHHSP |  | 3d | 2025-03-14 | 2025-03-18 |  | 2025-03-14 | 2025-03-18 | 0d |  |  | 722d |  | finish no earlier than 2025-03-18 |  | Business & Operation Readiness | 5.31 |  | 107.33 | Green | GREEN | MHHSP |  |  |  |  |
| 2822 | 1.9.2.7.5.1.6 | Non-SIT LDSO Service Activation Hypercare Complete (M) | milestone | 0d | 2025-03-18 | 2025-03-18 |  | 2025-03-18 | 2025-03-18 | 0d |  |  | 722d |  | finish no earlier than 2025-03-18 |  | Business & Operation Readiness | 5.31 |  | 111.71 | Green | GREEN |  |  |  |  |  |
| 2823 | 1.9.3 | **Implement Early Life Support Plan** |  | 55d | 2025-07-07 | 2025-09-19 |  | 2025-07-07 | 2025-09-19 | 45d | 2025-01-06 | 2025-02-28 | 589d |  |  | -0 | Business & Operation Readiness | 5.0 | N/A |  |  |  | N/A | N/A | Business & Operational Readiness |  |  |
| 2824 | 1.9.3.1 | Implement Early Life Support Plan |  | 55d | 2025-07-07 | 2025-09-19 |  | 2025-07-07 | 2025-09-19 | 45d | 2025-02-28 | 2025-02-28 | 589d |  | start no earlier than 2025-07-07 |  | Business & Operation Readiness | 5.23 | SI Transition | 222.33 | Green | GREEN | SI Transition,CPT | Matthew Breen | Business & Operational Readiness | MHHS-ART095 |  |
| 2825 | 1.9.4 | **Business Continuity and Disaster Recovery Plan** |  | 40d | 2025-07-30 | 2025-09-23 |  | 2025-07-31 | 2025-09-24 | 40d | 2025-01-13 | 2025-03-07 | 587d |  |  |  | Business & Operation Readiness | 5.0 | N/A |  |  |  | N/A | N/A | Business & Operational Readiness |  |  |
| 2826 | 1.9.4.1 | Central Parties BCDRs in Place |  | 20d | 2025-07-30 | 2025-08-26 | 2364FS-40d | 2025-07-31 | 2025-08-27 | 20d | 2025-01-13 | 2025-02-07 | 587d | 0d |  |  | Business & Operation Readiness | 5.0 | SI Design | 245.33 | Green | GREEN |  | MHHS Programme | Business & Operational Readiness |  |  |
| 2827 | 1.9.4.2 | Risk Based Assurance of Cental Party BCDRs |  | 20d | 2025-08-27 | 2025-09-23 | 2826 | 2025-08-28 | 2025-09-24 | 20d | 2025-02-10 | 2025-03-07 | 587d |  |  |  | Business & Operation Readiness | 5.0 | PP | 273.33 | Green | GREEN | SI Design | MHHS Programme | Business & Operational Readiness |  |  |
| 2828 | 1.9.5 | **Training and Support Materials** |  | 39d | 2025-08-20 | 2025-10-13 |  | 2025-08-21 | 2025-10-14 | 40d | 2025-02-03 | 2025-03-28 | 573d |  |  |  | Business & Operation Readiness | 5.0 | N/A |  |  |  | N/A | N/A | Business & Operational Readiness |  | 10/5: To be reworked with better clarity (LH) |
| 2829 | 1.9.5.1 | Develop document |  | 20d | 2025-08-20 | 2025-09-16 | 2615FS-45d | 2025-08-21 | 2025-09-17 | 20d | 2025-02-03 | 2025-02-28 | 573d | 0d |  |  | Business & Operation Readiness | 5.0 | SI Migration | 266.33 | Green | GREEN | CPT | PPC | Business & Operational Readiness |  |  |
| 2830 | 1.9.5.2 | Document review and update |  | 19d | 2025-09-17 | 2025-10-13 | 2829 | 2025-09-18 | 2025-10-14 | 20d | 2025-03-03 | 2025-03-28 | 573d | 0d |  |  | Business & Operation Readiness | 5.0 | SI Migration | 294.33 | Green | GREEN | PMO,CPT,IPA,PP | PPC | Business & Operational Readiness |  |  |
| 2831 | 1.9.5.3 | Training and Support Materials approved | milestone | 0d | 2025-10-13 | 2025-10-13 | 2830 | 2025-10-14 | 2025-10-14 | 0d | 2025-03-28 | 2025-03-28 | 573d |  |  |  | Business & Operation Readiness | 5.0 | SI Migration | 320.71 | Green | GREEN | PMO,CPT | PPC | Business & Operational Readiness | MHHS-ART118 |  |
| 2832 | 1.9.6 | **PP Business Change** |  | 129d | 2025-02-03 | 2025-07-31 |  | 2025-02-03 | 2025-07-31 | 129d | 2025-02-03 | 2025-07-31 | 625d |  |  |  | Business & Operation Readiness | 5.0 | N/A | M11 |  |  | N/A | N/A | Business & Operational Readiness |  | 10/5: Review with PPC (LH) |
| 2833 | 1.9.6.1 | Plan stakeholder management |  | 129d | 2025-02-03 | 2025-07-31 |  | 2025-02-03 | 2025-07-31 | 129d | 2025-02-03 | 2025-07-31 | 625d |  | start no earlier than 2025-02-03 |  | Business & Operation Readiness | 5.0 | PP | 68.33 | Green | GREEN | PPC | PPC | Business & Operational Readiness |  |  |
| 2834 | 1.9.6.2 | Manage stakeholders |  | 129d | 2025-02-03 | 2025-07-31 |  | 2025-02-03 | 2025-07-31 | 129d | 2025-02-03 | 2025-07-31 | 625d |  | start no earlier than 2025-02-03 |  | Business & Operation Readiness | 5.0 | PP | 68.33 | Green | GREEN | PPC | PPC | Business & Operational Readiness |  |  |
| 2835 | 1.9.6.3 | Develop & implement changes to KPIs, organisation & people management |  | 129d | 2025-02-03 | 2025-07-31 |  | 2025-02-03 | 2025-07-31 | 129d | 2025-02-03 | 2025-07-31 | 625d |  | start no earlier than 2025-02-03 |  | Business & Operation Readiness | 5.0 | PP | 68.33 | Green | GREEN | PPC | PPC | Business & Operational Readiness |  |  |
| 2836 | 1.9.6.4 | Develop & test changes to business processes |  | 129d | 2025-02-03 | 2025-07-31 |  | 2025-02-03 | 2025-07-31 | 129d | 2025-02-03 | 2025-07-31 | 625d |  | start no earlier than 2025-02-03 |  | Business & Operation Readiness | 5.0 | PP | 68.33 | Green | GREEN | PPC | PPC | Business & Operational Readiness |  |  |
| 2837 | 1.9.6.5 | Develop and deliver training |  | 129d | 2025-02-03 | 2025-07-31 |  | 2025-02-03 | 2025-07-31 | 129d | 2025-02-03 | 2025-07-31 | 625d |  | start no earlier than 2025-02-03 |  | Business & Operation Readiness | 5.0 | PP | 68.33 | Green | GREEN | PPC | PPC | Business & Operational Readiness |  |  |
| 2838 | 1.9.6.6 | Programme support for PP Business Change activities |  | 129d | 2025-02-03 | 2025-07-31 |  | 2025-02-03 | 2025-07-31 | 129d | 2025-02-03 | 2025-07-31 | 625d |  | start no earlier than 2025-02-03 |  | Business & Operation Readiness | 5.0 | PPC | 68.33 | Green | GREEN | PP | PPC | Business & Operational Readiness |  |  |

Notes:
- 2824: 12/11/24 - Once MCAG approval of Early Life Support Plan is secured, dependency will be added back in.

| ID | WBS | Task | Type | Duration | Start | Finish | Predecessors | Baseline start | Baseline finish | Baseline duration | Baseline 1 start | Baseline 1 finish | Total slack | Free slack | Baseline cost | Responsible | Involved | Text9 | Task Status | Update Version | MHHS Resource Name | MHHS Programme Phase | Sched Status | RAG | Milestone ID | Text29 | Tier | Future RAG | Artefact ID |
| --- | --- | --- | --- | --- | --- | --- | --- | --- | --- | --- | --- | --- | --- | --- | --- | --- | --- | --- | --- | --- | --- | --- | --- | --- | --- | --- | --- | --- | --- |
| 2839 | 1.9.7 | **Transition to New Settlement Timetable (M16)** |  | 567d | 2025-10-21 | 2027-12-23 |  | 2025-10-22 | 2027-12-23 | 560d |  |  | 0d |  | -0 | N/A | N/A | Business & Operation Readiness | -434.67 | 5.15 | N/A | Business & Operational Readiness |  |  |  |  |  |  |  |
| 2840 | 1.9.7.1 | Elexon to produce Settlement Calendar for Settlement Year 2025/2026 | milestone | 0d | 2025-10-21 | 2025-10-21 | 2613 | 2025-10-22 | 2025-10-22 | 0d |  |  | 6d | 0d |  | PP | PP, Code Bodies | Business & Operation Readiness | 328.71 | 5.15 | Matthew Breen | Business & Operational Readiness | Green | GREEN |  |  |  |  |  |
| 2841 | 1.9.7.2 | Elexon monitor settlement data of migrated MPANs |  | 436d | 2025-10-22 | 2027-06-23 | 2840 | 2025-10-23 | 2027-06-24 | 436d |  |  | 7d |  |  | PP | PP, Code Bodies | Business & Operation Readiness | 329.33 | 5.15 | Matthew Breen | Business & Operational Readiness | Green | GREEN |  |  |  |  |  |
| 2842 | 1.9.7.3 | M16 Checkpoint 1 | milestone | 0d | 2026-06-24 | 2026-06-24 | 2840FS+176d | 2026-06-25 | 2026-06-25 | 0d |  |  | 6d | 0d |  | PP | PP, Code Bodies | Business & Operation Readiness | 574.71 | 5.15 | Matthew Breen | Business & Operational Readiness | Green | GREEN |  |  |  |  |  |
| 2843 | 1.9.7.4 | Confirm if M16 date retained as 07/12/2026 | milestone | 0d | 2026-07-22 | 2026-07-22 | 2842FS+20d | 2026-07-23 | 2026-07-23 | 0d |  |  | 6d | 0d |  | CPT | PP | Business & Operation Readiness | 602.71 | 5.15 | Matthew Breen | Business & Operational Readiness | Green | GREEN |  |  |  |  |  |
| 2844 | 1.9.7.5 | Readiness assessment of participants' readiness to transition to new Settlement Timetable | milestone | 0d | 2026-08-19 | 2026-08-19 | 2843FS+20d | 2026-08-20 | 2026-08-20 | 0d |  |  | 6d | 0d |  | CPT | PP | Business & Operation Readiness | 630.71 | 5.15 | Matthew Breen | Business & Operational Readiness | Green | GREEN |  |  |  |  |  |
| 2845 | 1.9.7.6 | Elexon to produce Settlement Calendar for Settlement Year 2026 up until day before M16 cutover | milestone | 0d | 2026-10-16 | 2026-10-16 | 2844FS+42d | 2026-10-19 | 2026-10-19 | 0d |  |  | 6d | 0d |  | PP | PP, Code Bodies | Business & Operation Readiness | 688.71 | 5.15 | Matthew Breen | Business & Operational Readiness | Green | GREEN |  |  |  |  |  |
| 2846 | 1.9.7.7 | M16 Checkpoint 2 | milestone | 0d | 2027-04-01 | 2027-04-01 | 2845FS+119d | 2027-04-02 | 2027-04-02 | 0d |  |  | 6d | 0d |  | PP | PP, Code Bodies | Business & Operation Readiness | 855.71 | 5.15 | Matthew Breen | Business & Operational Readiness | Green | GREEN |  |  |  |  |  |
| 2847 | 1.9.7.8 | Readiness assessment of participants' readiness to transition to new Settlement Timetable | milestone | 0d | 2027-04-16 | 2027-04-16 | 2846FS+11d | 2027-04-19 | 2027-04-19 | 0d |  |  | 6d | 0d |  | CPT | PP | Business & Operation Readiness | 870.71 | 5.15 | Matthew Breen | Business & Operational Readiness | Green | GREEN |  |  |  |  |  |
| 2848 | 1.9.7.9 | Confirm M16 Date | milestone | 0d | 2027-04-29 | 2027-04-29 | 2847FS+9d | 2027-04-30 | 2027-04-30 | 1d |  |  | 6d | 0d |  | CPT | Code Bodies,CPT,PP,SRO | Business & Operation Readiness | 883.71 | 5.3 | Matthew Breen | Business & Operational Readiness | Green | GREEN | T2-EL-0100 | PSG/BSC PAB | T2 |  |  |
| 2849 | 1.9.7.10 | Raise fast track change to ISD (November publish) | milestone | 0d | 2027-04-29 | 2027-04-29 | 2848 | 2027-04-30 | 2027-04-30 | 0d |  |  | 46d |  |  | PP | PP,CPT,Code Bodies | Business & Operation Readiness | 883.71 | 5.15 | Matthew Breen | Business & Operational Readiness | Green | GREEN |  |  |  |  |  |
| 2850 | 1.9.7.11 | **M16 Approval Window** |  | 130d | 2027-06-24 | 2027-12-23 |  | 2027-06-25 | 2027-12-23 | 124d | 2026-12-07 | 2027-05-24 | 0d |  |  | N/A | N/A | Business & Operation Readiness | 966.71 | 5.0 | N/A | Business & Operational Readiness | Green | GREEN |  |  |  |  |  |
| 2851 | 1.9.7.11.1 | Panel approval that M16 criteria met | milestone | 0d | 2027-06-24 | 2027-06-24 | 2848FS+40d | 2027-06-25 | 2027-06-25 | 0d | 2026-12-07 | 2026-12-07 | 6d |  |  | Panel | Code Bodies,CPT,PP,SRO | Business & Operation Readiness | 939.71 | 5.0 | Matthew Breen | Business & Operational Readiness | Green | GREEN |  |  |  |  |  |
| 2852 | 1.9.7.11.2 | Cut over to new settlement timetable (M16) | milestone | 0d | 2027-07-02 | 2027-07-02 | 2851, 2617FS+40d, 2841, 2849, 2527 | 2027-07-02 | 2027-07-02 | 0d | 2026-12-07 | 2026-12-07 | 0d |  |  | CPT | PP | Business & Operation Readiness | 947.71 | 5.0 | Matthew Breen | Business & Operational Readiness | Green | GREEN | T1-EL-1000 | PSG | T1 |  |  |
| 2853 | 1.9.7.11.3 | Maximum 6-month window for approval of M16 |  | 124d | 2027-07-05 | 2027-12-23 | 2852 | 2027-07-05 | 2027-12-23 | 124d | 2026-12-08 | 2027-05-24 | 0d |  |  | CPT |  | Business & Operation Readiness | 950.33 | 5.0 | Matthew Breen | Business & Operational Readiness | Green | GREEN |  |  |  |  |  |
| 2854 | 1.9.7.11.4 | Cut over to new settlement timetable (M16*) - Late Exit | milestone | 0d | 2027-12-23 | 2027-12-23 | 2853 | 2027-12-23 | 2027-12-23 | 0d | 2027-05-24 | 2027-05-24 | 0d |  |  | CPT | PP | Business & Operation Readiness | 1121.71 | 5.0 | Matthew Breen | Business & Operational Readiness | Green | GREEN | T1-EL-2000 | PSG | T1 |  |  |
| 2855 | 1.10 | **EARLY LIVE RUNNING** |  | 45d | 2027-05-10 | 2027-07-09 |  | 2027-05-10 | 2027-07-09 | 889d | 2024-01-02 | 2027-05-28 | 119d |  |  | N/A | N/A | Business & Operation Readiness |  |  | N/A | Early Live Running |  |  |  |  |  | 1 Nov 2025 - 30 Apr 2026 |  |
| 2856 | 1.10.1 | **Early Live Running Stabilisation Period** |  | 45d | 2027-05-10 | 2027-07-09 |  | 2027-05-10 | 2027-07-09 | 45d | 2026-10-06 | 2026-12-07 | 119d |  |  | N/A | N/A | Business & Operation Readiness |  | 5.0 | N/A | Early Live Running |  |  |  |  |  |  |  |
| 2857 | 1.10.1.1 | Manage Early Live Running stabilisation period |  | 45d | 2027-05-10 | 2027-07-09 | 2617 | 2027-05-10 | 2027-07-09 | 45d | 2026-10-06 | 2026-12-07 | 119d | 0d |  | Code Bodies | PP | Business & Operation Readiness | 894.33 | 5.0 | Matthew Breen | Early Live Running | Green | GREEN |  |  |  |  |  |
| 2858 | 1.10.1.2 | Monitor Early Live Running stabilisation period |  | 45d | 2027-05-10 | 2027-07-09 | 2857SS | 2027-05-10 | 2027-07-09 | 45d | 2026-10-06 | 2026-12-07 | 119d |  |  | SI Migration | Code Bodies,PP | Business & Operation Readiness | 894.33 | 5.0 | Matthew Breen | Early Live Running | Green | GREEN |  |  |  |  |  |
| 2859 | 1.11 | **PROGRAMME CLOSURE** |  | 80d | 2027-03-08 | 2027-06-25 |  | 2027-03-08 | 2027-06-25 | 85d | 2026-08-04 | 2026-11-30 | 129d |  |  | N/A | N/A | Programme Closure |  |  | N/A | Programme Closure |  |  |  |  |  |  |  |
| 2860 | 1.11.1 | **Handover Pack** |  | 80d | 2027-03-08 | 2027-06-25 |  | 2027-03-08 | 2027-06-25 | 85d | 2026-08-04 | 2026-11-30 | 129d |  |  | N/A | N/A | Programme Closure |  | 5.0 | N/A | Programme Closure |  |  |  |  |  |  |  |
| 2861 | 1.11.1.1 | **Draft Handover Pack (for M15)** |  | 40d | 2027-03-08 | 2027-04-30 |  | 2027-03-08 | 2027-04-30 | 40d | 2026-08-04 | 2026-09-28 | 169d |  |  | N/A | N/A | Programme Closure |  | 5.0 | N/A | Programme Closure |  |  |  |  |  |  |  |
| 2862 | 1.11.1.1.1 | Develop document |  | 20d | 2027-03-08 | 2027-04-02 | 2617FS-45d | 2027-03-08 | 2027-04-02 | 20d | 2026-08-04 | 2026-08-31 | 169d | 0d |  | PMO | CPT | Programme Closure | 831.33 | 5.0 |  | Programme Closure | Green | GREEN |  |  |  |  |  |
| 2863 | 1.11.1.1.2 | Document review and update |  | 20d | 2027-04-05 | 2027-04-30 | 2862 | 2027-04-05 | 2027-04-30 | 20d | 2026-09-01 | 2026-09-28 | 169d | 0d |  | SRO | PMO,CPT,IPA,PP | Programme Closure | 859.33 | 5.0 |  | Programme Closure | Green | GREEN |  |  |  |  |  |
| 2864 | 1.11.1.1.3 | Draft Handover Pack approved | milestone | 0d | 2027-04-30 | 2027-04-30 | 2863 | 2027-04-30 | 2027-04-30 | 0d | 2026-09-28 | 2026-09-28 | 169d |  |  | SRO | PMO,CPT | Programme Closure | 884.71 | 5.0 |  | Programme Closure | Green | GREEN |  |  |  |  | MHHS-ART126 |

| ID | WBS | Task | Type | Duration | Start | Finish | Predecessors | Baseline start | Baseline finish | Baseline duration | Baseline 1 start | Baseline 1 finish | Total slack | Free slack | Responsible | Involved | Text9 | Update Version | MHHS Resource Name | MHHS Programme Phase | Task Status | Sched Status | RAG | Artefact ID | Milestone ID | Text29 | Tier |
| --- | --- | --- | --- | --- | --- | --- | --- | --- | --- | --- | --- | --- | --- | --- | --- | --- | --- | --- | --- | --- | --- | --- | --- | --- | --- | --- | --- |
| 2865 | 1.11.1.2 | **Master Handover Pack (for M16)** |  | 40d | 2027-05-03 | 2027-06-25 |  | 2027-05-03 | 2027-06-25 | 40d | 2026-10-06 | 2026-11-30 | 129d |  | N/A | N/A | Programme Closure | 5.0 | N/A | Programme Closure |  |  |  |  |  |  |  |
| 2866 | 1.11.1.2.1 | Update document |  | 20d | 2027-05-03 | 2027-05-28 | 2852FS-45d | 2027-05-03 | 2027-05-28 | 20d | 2026-10-06 | 2026-11-02 | 129d | 0d | PMO | CPT | Programme Closure | 5.0 |  | Programme Closure | 887.33 | Green | GREEN |  |  |  |  |
| 2867 | 1.11.1.2.2 | Document review and update |  | 20d | 2027-05-31 | 2027-06-25 | 2866 | 2027-05-31 | 2027-06-25 | 20d | 2026-11-03 | 2026-11-30 | 129d | 0d | SRO | PMO,CPT,IPA,PP | Programme Closure | 5.0 |  | Programme Closure | 915.33 | Green | GREEN |  |  |  |  |
| 2868 | 1.11.1.2.3 | Master Handover Pack approved | milestone | 0d | 2027-06-25 | 2027-06-25 | 2867 | 2027-06-25 | 2027-06-25 | 0d | 2026-11-30 | 2026-11-30 | 129d |  | SRO | PMO,CPT | Programme Closure | 5.0 |  | Programme Closure | 940.71 | Green | GREEN | MHHS-ART126 |  |  |  |
| 2869 | 1.11.2 | **Programme Lessons Learned** |  | 40d | 2027-03-08 | 2027-04-30 |  | 2027-03-08 | 2027-04-30 | 40d | 2026-08-04 | 2026-09-28 | 169d |  | N/A | N/A | Programme Closure | 5.0 | N/A | Programme Closure |  |  |  |  |  |  |  |
| 2870 | 1.11.2.1 | Develop document |  | 20d | 2027-03-08 | 2027-04-02 | 2617FS-45d | 2027-03-08 | 2027-04-02 | 20d | 2026-08-04 | 2026-08-31 | 169d | 0d | PMO | CPT | Programme Closure | 5.0 |  | Programme Closure | 831.33 | Green | GREEN |  |  |  |  |
| 2871 | 1.11.2.2 | Document review and update |  | 20d | 2027-04-05 | 2027-04-30 | 2870 | 2027-04-05 | 2027-04-30 | 20d | 2026-09-01 | 2026-09-28 | 169d | 0d | SRO | PMO,CPT,IPA | Programme Closure | 5.0 |  | Programme Closure | 859.33 | Green | GREEN |  |  |  |  |
| 2872 | 1.11.2.3 | Programme Lessons Learned document approved | milestone | 0d | 2027-04-30 | 2027-04-30 | 2871 | 2027-04-30 | 2027-04-30 | 0d | 2026-09-28 | 2026-09-28 | 169d |  | SRO | PMO,CPT | Programme Closure | 5.0 |  | Programme Closure | 884.71 | Green | GREEN | MHHS-ART131 |  |  |  |
| 2873 | 1.11.3 | **Programme Closure Report** |  | 40d | 2027-03-08 | 2027-04-30 |  | 2027-03-08 | 2027-04-30 | 40d | 2026-08-04 | 2026-09-28 | 169d |  | N/A | N/A | Programme Closure | 5.0 | N/A | Programme Closure |  |  |  |  |  |  |  |
| 2874 | 1.11.3.1 | Develop document |  | 20d | 2027-03-08 | 2027-04-02 | 2617FS-45d | 2027-03-08 | 2027-04-02 | 20d | 2026-08-04 | 2026-08-31 | 169d | 0d | PMO | CPT | Programme Closure | 5.0 |  | Programme Closure | 831.33 | Green | GREEN |  |  |  |  |
| 2875 | 1.11.3.2 | Document review and update |  | 20d | 2027-04-05 | 2027-04-30 | 2874 | 2027-04-05 | 2027-04-30 | 20d | 2026-09-01 | 2026-09-28 | 169d | 0d | Ofgem | PMO,CPT,IPA,SRO | Programme Closure | 5.0 |  | Programme Closure | 859.33 | Green | GREEN |  |  |  |  |
| 2876 | 1.11.3.3 | Programme Closure Report approved | milestone | 0d | 2027-04-30 | 2027-04-30 | 2875 | 2027-04-30 | 2027-04-30 | 0d | 2026-09-28 | 2026-09-28 | 169d |  | Ofgem | PMO,CPT,IPA,SRO | Programme Closure | 5.0 |  | Programme Closure | 884.71 | Green | GREEN | MHHS-ART130 |  |  |  |
| 2877 | 1.11.4 | **Benefit Realisation Report** |  | 45d | 2027-03-08 | 2027-05-07 |  | 2027-03-08 | 2027-05-07 | 45d | 2026-08-04 | 2026-10-05 | 164d |  | N/A | N/A | Programme Closure | 5.0 | N/A | Programme Closure |  |  |  |  |  |  |  |
| 2878 | 1.11.4.1 | Develop document |  | 20d | 2027-03-08 | 2027-04-02 | 2617FS-45d | 2027-03-08 | 2027-04-02 | 20d | 2026-08-04 | 2026-08-31 | 164d | 0d | PMO | CPT | Programme Closure | 5.0 |  | Programme Closure | 831.33 | Green | GREEN |  |  |  |  |
| 2879 | 1.11.4.2 | Document review and update |  | 20d | 2027-04-05 | 2027-04-30 | 2878 | 2027-04-05 | 2027-04-30 | 20d | 2026-09-01 | 2026-09-28 | 164d | 0d | PP | PMO,CPT,IPA,SRO | Programme Closure | 5.0 |  | Programme Closure | 859.33 | Green | GREEN |  |  |  |  |
| 2880 | 1.11.4.3 | Benefit Realisation Report approved | milestone | 0d | 2027-05-07 | 2027-05-07 | 2879FS+5d | 2027-05-07 | 2027-05-07 | 0d | 2026-10-05 | 2026-10-05 | 164d |  | PMO | CPT,PP,IPA,SRO | Programme Closure | 5.0 |  | Programme Closure | 891.71 | Green | GREEN | MHHS-ART124 | T3-PC-0010 | PSG | T3 |
| 2881 | 1.11.5 | **Operating Model Gap Review with recommendations** |  | 45d | 2027-03-08 | 2027-05-07 |  | 2027-03-08 | 2027-05-07 | 45d | 2026-08-04 | 2026-10-05 | 164d |  | N/A | N/A | Programme Closure | 5.0 | N/A | Programme Closure |  |  |  |  |  |  |  |
| 2882 | 1.11.5.1 | Develop document |  | 20d | 2027-03-08 | 2027-04-02 | 2617FS-45d | 2027-03-08 | 2027-04-02 | 20d | 2026-08-04 | 2026-08-31 | 164d | 0d | PMO | CPT | Programme Closure | 5.0 |  | Programme Closure | 831.33 | Green | GREEN |  |  |  |  |
| 2883 | 1.11.5.2 | Document review and update |  | 20d | 2027-04-05 | 2027-04-30 | 2882 | 2027-04-05 | 2027-04-30 | 20d | 2026-09-01 | 2026-09-28 | 164d | 0d | PP | PMO,CPT,IPA,SRO | Programme Closure | 5.0 |  | Programme Closure | 859.33 | Green | GREEN |  |  |  |  |
| 2884 | 1.11.5.3 | Operating Model Gap Review with recommendations approved | milestone | 0d | 2027-05-07 | 2027-05-07 | 2883FS+5d | 2027-05-07 | 2027-05-07 | 0d | 2026-10-05 | 2026-10-05 | 164d |  | Paul Pettitt | CPT,PP,IPA,SRO | Programme Closure | 5.0 | Paul Pettitt | Programme Closure | 891.71 | Green | GREEN | MHHS-ART128 | T3-PC-0020 | DAG | T3 |
| 2885 | 1.11.6 | **Post-Implementation Review** |  | 45d | 2027-03-08 | 2027-05-07 |  | 2027-03-08 | 2027-05-07 | 45d | 2026-08-04 | 2026-10-05 | 164d |  | N/A | N/A | Programme Closure | 5.0 | N/A | Programme Closure |  |  |  |  |  |  |  |
| 2886 | 1.11.6.1 | Develop document |  | 20d | 2027-03-08 | 2027-04-02 | 2617FS-45d | 2027-03-08 | 2027-04-02 | 20d | 2026-08-04 | 2026-08-31 | 164d | 0d | PMO | CPT | Programme Closure | 5.0 |  | Programme Closure | 831.33 | Green | GREEN |  |  |  |  |
| 2887 | 1.11.6.2 | Document review and update |  | 20d | 2027-04-05 | 2027-04-30 | 2886 | 2027-04-05 | 2027-04-30 | 20d | 2026-09-01 | 2026-09-28 | 164d | 0d | PP | PMO,CPT,IPA,SRO | Programme Closure | 5.0 |  | Programme Closure | 859.33 | Green | GREEN |  |  |  |  |
| 2888 | 1.11.6.3 | Post-Implementation Review approved | milestone | 0d | 2027-05-07 | 2027-05-07 | 2887FS+5d | 2027-05-07 | 2027-05-07 | 0d | 2026-10-05 | 2026-10-05 | 164d |  | PMO | CPT,PP,IPA,SRO | Programme Closure | 5.0 |  | Programme Closure | 891.71 | Green | GREEN | MHHS-ART129 | T3-PC-0030 | PSG | T3 |

Notes:
- 2884: Action: 5/2 - PP said ask MB if belonged to him. MB says doesn't sit with him

| ID | WBS | Task | Type | Duration | Start | Finish | Predecessors | Complete | Remaining | Baseline start | Baseline finish | Baseline duration | Baseline 1 start | Baseline 1 finish | Total slack | Free slack | Constraint | Responsible | Involved | Text9 | Update Version | MHHS Resource Name | MHHS Programme Phase | Task Status | Sched Status | RAG | Artefact ID | Milestone ID | Text29 | Tier | Future RAG |
| --- | --- | --- | --- | --- | --- | --- | --- | --- | --- | --- | --- | --- | --- | --- | --- | --- | --- | --- | --- | --- | --- | --- | --- | --- | --- | --- | --- | --- | --- | --- | --- |
| 2889 | 1.11.7 | **Reinforcement Guide** |  | 45d | 2027-03-08 | 2027-05-07 |  |  |  | 2027-03-08 | 2027-05-07 | 45d | 2026-08-04 | 2026-10-05 | 164d |  |  | N/A | N/A | Programme Closure | 5.0 | N/A | Programme Closure |  |  |  |  |  |  |  |  |
| 2890 | 1.11.7.1 | Develop document |  | 20d | 2027-03-08 | 2027-04-02 | 2617FS-45d |  |  | 2027-03-08 | 2027-04-02 | 20d | 2026-08-04 | 2026-08-31 | 164d | 0d |  | PMO | CPT | Programme Closure | 5.0 |  | Programme Closure | 831.33 | Green | GREEN |  |  |  |  |  |
| 2891 | 1.11.7.2 | Document review and update |  | 20d | 2027-04-05 | 2027-04-30 | 2890 |  |  | 2027-04-05 | 2027-04-30 | 20d | 2026-09-01 | 2026-09-28 | 164d | 0d |  | PP | PMO,CPT,IPA,SRO | Programme Closure | 5.0 |  | Programme Closure | 859.33 | Green | GREEN |  |  |  |  |  |
| 2892 | 1.11.7.3 | Reinforcement Guide approved | milestone | 0d | 2027-05-07 | 2027-05-07 | 2891FS+5d |  |  | 2027-05-07 | 2027-05-07 | 0d | 2026-10-05 | 2026-10-05 | 164d |  |  | PMO | CPT,PP,IPA,SRO | Programme Closure | 5.0 |  | Programme Closure | 891.71 | Green | GREEN | MHHS-ART133 | T3-PC-0040 | PSG | T3 |  |
| 2893 | 1.11.8 | **Material and Licenses Transfer** |  | 60d | 2027-04-05 | 2027-06-25 |  |  |  | 2027-04-05 | 2027-06-25 | 60d | 2026-09-08 | 2026-11-30 | 129d |  |  | N/A | N/A | Programme Closure | 5.0 | N/A | Programme Closure |  |  |  |  |  |  |  |  |
| 2894 | 1.11.8.1 | Transfer of Programme material to Elexon and perpetual licenses as appropriate |  | 60d | 2027-04-05 | 2027-06-25 | 2852FF-5d |  |  | 2027-04-05 | 2027-06-25 | 60d | 2026-09-08 | 2026-11-30 | 129d |  |  | PMO | CPT,PP | Programme Closure | 5.0 |  | Programme Closure | 859.33 | Green | GREEN | MHHS-ART139 |  |  |  |  |
| 2895 | 1.12 | **READINESS ASSESSMENTS** |  | 988d | 2023-09-05 A | 2027-06-17 |  | 23% | 764.9d | 2023-09-05 | 2027-06-17 | 849d | 2023-09-11 | 2026-12-04 | 135d |  |  | N/A | N/A | Readiness Assessment |  | N/A | Readiness Assessments |  |  |  |  |  |  |  |  |
| 2896 | 1.12.1 | **Readiness Assessment 3 - Design and Build Progress Check and CP2 Check** |  | 60d | 2023-09-05 A | 2023-11-27 A |  | 100% |  | 2023-09-05 | 2023-11-27 | 50d | 2023-09-11 | 2023-11-17 |  |  |  | N/A | N/A | Readiness Assessment | 5.5 | N/A | Readiness Assessments | M5,M6 |  |  |  |  |  |  |  |
| 2897 | 1.12.1.1 | Launch Readiness Assessment survey | milestone | 0d | 2023-09-05 A | 2023-09-05 A | 1432FS-40d | 100% |  | 2023-09-05 | 2023-09-05 | 0d | 2023-09-11 | 2023-09-11 |  |  |  | PPC |  | Readiness Assessment | 5.5 | PPC | Readiness Assessments |  | Complete | COMPLETE |  |  |  |  |  |
| 2898 | 1.12.1.2 | PPs submit survey responses |  | 15d | 2023-09-05 A | 2023-09-25 A | 2897 | 100% |  | 2023-09-05 | 2023-09-25 | 15d | 2023-09-11 | 2023-09-29 |  |  |  | PP | PPC | Readiness Assessment | 5.5 | PPC | Readiness Assessments |  | Complete | COMPLETE |  |  |  |  |  |
| 2899 | 1.12.1.3 | Analyse survey responses |  | 15d | 2023-09-26 A | 2023-10-16 A | 2898 | 100% |  | 2023-09-26 | 2023-10-16 | 15d | 2023-10-02 | 2023-10-20 |  |  |  | PPC | CPT | Readiness Assessment | 5.5 | PPC | Readiness Assessments |  | Complete | COMPLETE |  |  |  |  |  |
| 2900 | 1.12.1.4 | Conduct deep-dive interviews (sample of PPs) |  | 15d | 2023-09-26 A | 2023-10-16 A | 2898 | 100% |  | 2023-09-26 | 2023-10-16 | 15d | 2023-10-02 | 2023-10-20 |  |  |  | PPC | CPT | Readiness Assessment | 5.5 | PPC | Readiness Assessments |  | Complete | COMPLETE |  |  |  |  |  |
| 2901 | 1.12.1.5 | Produce Readiness Assessment Reports (Overall Report & Individual Participant Reports) |  | 25d | 2023-10-17 A | 2023-11-20 A | 2899, 2900 | 100% |  | 2023-10-17 | 2023-11-20 | 15d | 2023-10-23 | 2023-11-10 |  |  |  | PPC |  | Readiness Assessment | 5.5 | PPC | Readiness Assessments |  | Complete | COMPLETE |  |  |  |  |  |
| 2902 | 1.12.1.6 | Readiness Assessment 3 - Design & Build Checkpoint 1 - Completed (incl. Readiness Assessment Report approval) | milestone | 0d | 2023-11-27 A | 2023-11-27 A | 2901FS+5d | 100% |  | 2023-11-27 | 2023-11-27 | 0d | 2023-11-17 | 2023-11-17 |  |  |  | CPT | PPC | Readiness Assessment | 5.13 | PPC | Readiness Assessments |  | Complete | COMPLETE |  | T2-RA-0200 | PSG | T2 |  |
| 2903 | 1.12.2 | **Readiness Assessment 5 / 6 - Start of Qualification and Participant Readiness for M10 and M11 and CP3/CP4 check** |  | 47d | 2025-04-21 | 2025-06-24 |  |  |  | 2025-04-21 | 2025-06-24 | 49d | 2024-11-12 | 2025-01-17 | 652d |  |  | N/A | N/A | Readiness Assessment | 5.0 | N/A | Readiness Assessments | M11 |  |  |  |  |  |  | D25 - RA6 Readiness Report |
| 2904 | 1.12.2.1 | Launch Readiness Assessment survey | milestone | 0d | 2025-04-21 | 2025-04-21 |  |  |  | 2025-04-21 | 2025-04-21 | 0d | 2024-11-12 | 2024-11-12 | 652d | 0d | start no earlier than 2025-04-21 | PPC |  | Readiness Assessment | 5.0 | PPC | Readiness Assessments | 145.33 | Green | GREEN |  |  |  |  |  |
| 2905 | 1.12.2.2 | PPs submit survey responses |  | 15d | 2025-04-21 | 2025-05-09 | 2904 |  |  | 2025-04-21 | 2025-05-09 | 15d | 2024-11-12 | 2024-12-02 | 652d | 0d |  | PP | PPC | Readiness Assessment | 5.0 | PPC | Readiness Assessments | 145.33 | Green | GREEN |  |  |  |  |  |
| 2906 | 1.12.2.3 | Analyse survey responses |  | 15d | 2025-05-12 | 2025-05-30 | 2905 |  |  | 2025-05-12 | 2025-05-30 | 15d | 2024-12-03 | 2024-12-23 | 652d | 0d |  | PPC | CPT | Readiness Assessment | 5.0 | PPC | Readiness Assessments | 166.33 | Green | GREEN |  |  |  |  |  |
| 2907 | 1.12.2.4 | Conduct deep-dive interviews (sample of PPs) |  | 15d | 2025-05-12 | 2025-05-30 | 2905 |  |  | 2025-05-12 | 2025-05-30 | 15d | 2024-12-03 | 2024-12-23 | 652d | 0d |  | PPC | CPT | Readiness Assessment | 5.0 | PPC | Readiness Assessments | 166.33 | Green | GREEN |  |  |  |  |  |
| 2908 | 1.12.2.5 | Produce Readiness Assessment Reports (Overall Report & Individual Participant Reports) |  | 15d | 2025-06-02 | 2025-06-20 | 2906, 2907 |  |  | 2025-06-02 | 2025-06-20 | 15d | 2024-12-24 | 2025-01-13 | 652d | 0d |  | PPC |  | Readiness Assessment | 5.0 | PPC | Readiness Assessments | 187.33 | Green | GREEN |  |  |  |  |  |
| 2909 | 1.12.2.6 | Readiness Assessment 5 / 6 - Start of Qualification and Participant Readiness for M10 and M11 and CP3/CP4 check (incl. Readiness Assessment Report approval) Completed | milestone | 0d | 2025-06-24 | 2025-06-24 | 2908FS+2d |  |  | 2025-06-24 | 2025-06-24 | 0d | 2025-01-17 | 2025-01-17 | 652d | 0d |  | CPT | PPC | Readiness Assessment | 5.18 | PPC | Readiness Assessments | 209.71 | Green | GREEN |  | T2-RA-0400 | PSG | T2 |  |
| 2910 | 1.12.3 | **Readiness Assessment 7 - Migration Checkpoint** |  | 49d | 2026-01-12 | 2026-03-19 |  |  |  | 2026-01-12 | 2026-03-19 | 49d | 2025-08-04 | 2025-10-09 | 460d |  |  | N/A | N/A | Readiness Assessment | 5.0 | N/A | Readiness Assessments | M14 |  |  |  |  |  |  | D29 - RA8 Readiness Report |
| 2911 | 1.12.3.1 | Launch Readiness Assessment survey | milestone | 0d | 2026-01-12 | 2026-01-12 |  |  |  | 2026-01-12 | 2026-01-12 | 0d | 2025-08-04 | 2025-08-04 | 460d | 0d | start no earlier than 2026-01-12 | PPC |  | Readiness Assessment | 5.0 | PPC | Readiness Assessments | 411.33 | Green | GREEN |  |  |  |  |  |
| 2912 | 1.12.3.2 | PPs submit survey responses |  | 15d | 2026-01-12 | 2026-01-30 | 2911 |  |  | 2026-01-12 | 2026-01-30 | 15d | 2025-08-04 | 2025-08-22 | 460d | 0d |  | PP | PPC | Readiness Assessment | 5.0 | PPC | Readiness Assessments | 411.33 | Green | GREEN |  |  |  |  |  |
| 2913 | 1.12.3.3 | Analyse survey responses |  | 15d | 2026-02-02 | 2026-02-20 | 2912 |  |  | 2026-02-02 | 2026-02-20 | 15d | 2025-08-25 | 2025-09-12 | 460d | 0d |  | PPC | CPT | Readiness Assessment | 5.0 | PPC | Readiness Assessments | 432.33 | Green | GREEN |  |  |  |  |  |
| 2914 | 1.12.3.4 | Conduct deep-dive interviews (sample of PPs) |  | 15d | 2026-02-02 | 2026-02-20 | 2912 |  |  | 2026-02-02 | 2026-02-20 | 15d | 2025-08-25 | 2025-09-12 | 460d | 0d |  | PPC | CPT | Readiness Assessment | 5.0 | PPC | Readiness Assessments | 432.33 | Green | GREEN |  |  |  |  |  |
| 2915 | 1.12.3.5 | Produce Readiness Assessment Reports (Overall Report & Individual Participant Reports) |  | 15d | 2026-02-23 | 2026-03-13 | 2913, 2914 |  |  | 2026-02-23 | 2026-03-13 | 15d | 2025-09-15 | 2025-10-03 | 460d | 0d |  | PPC |  | Readiness Assessment | 5.0 | PPC | Readiness Assessments | 453.33 | Green | GREEN |  |  |  |  |  |
| 2916 | 1.12.3.6 | Readiness Assessment 7 - Migration Checkpoint - Completed (incl. Readiness Assessment Report approval) | milestone | 0d | 2026-03-19 | 2026-03-19 | 2915FS+4d |  |  | 2026-03-19 | 2026-03-19 | 0d | 2025-10-09 | 2025-10-09 | 460d | 0d |  | CPT | PPC | Readiness Assessment | 5.0 | PPC | Readiness Assessments | 477.71 | Green | GREEN |  | T2-RA-0600 | PSG | T2 |  |

Notes:
- 2900: 16/11- FD confirmed activity didn't take place for RA3 because responses did not warrant follow-up
- 2902: 16/11-RA3 outputs and initial findings shared with PSG to support M9 decision making. Individual reports and final closure report being finalised. No impact to Programme timelines or activities
- 2909: 08/02/2024 Name change approval at PSG on 07/02/24 from Readiness Assessment 5 - Start of Qualification - Completed (incl. Readiness Assessment Report approval)

| ID | WBS | Task | Type | Duration | Start | Finish | Predecessors | Complete | Remaining | Baseline start | Baseline finish | Baseline duration | Baseline 1 start | Baseline 1 finish | Total slack | Free slack | Constraint | Responsible | Involved | Future RAG | Text9 | Task Status | Update Version | MHHS Resource Name | MHHS Programme Phase | Sched Status | RAG | Milestone ID | Text29 | Tier |
| --- | --- | --- | --- | --- | --- | --- | --- | --- | --- | --- | --- | --- | --- | --- | --- | --- | --- | --- | --- | --- | --- | --- | --- | --- | --- | --- | --- | --- | --- | --- |
| 2917 | 1.12.4 | **Readiness Assessment 8 - Ready to Accept New MPANs** |  | 49d | 2026-08-06 | 2026-10-13 |  |  |  | 2026-08-06 | 2026-10-13 | 49d | 2026-01-06 | 2026-03-13 | 312d |  |  | N/A | N/A | D29 - RA8 Readiness Report | Readiness Assessment | M14 | 5.0 | N/A | Readiness Assessments |  |  |  |  |  |
| 2918 | 1.12.4.1 | Launch Readiness Assessment survey | milestone | 0d | 2026-08-06 | 2026-08-06 | 2229FS-60d |  |  | 2026-08-06 | 2026-08-06 | 0d | 2026-01-06 | 2026-01-06 | 312d | 0d |  | PPC |  |  | Readiness Assessment | 617.33 | 5.0 | PPC | Readiness Assessments | Green | GREEN |  |  |  |
| 2919 | 1.12.4.2 | PPs submit survey responses |  | 15d | 2026-08-06 | 2026-08-26 | 2918 |  |  | 2026-08-06 | 2026-08-26 | 15d | 2026-01-06 | 2026-01-26 | 312d | 0d |  | PP | PPC |  | Readiness Assessment | 617.33 | 5.0 | PPC | Readiness Assessments | Green | GREEN |  |  |  |
| 2920 | 1.12.4.3 | Analyse survey responses |  | 15d | 2026-08-27 | 2026-09-16 | 2919 |  |  | 2026-08-27 | 2026-09-16 | 15d | 2026-01-27 | 2026-02-16 | 312d | 0d |  | PPC | CPT |  | Readiness Assessment | 638.33 | 5.0 | PPC | Readiness Assessments | Green | GREEN |  |  |  |
| 2921 | 1.12.4.4 | Conduct deep-dive interviews (sample of PPs) |  | 15d | 2026-08-27 | 2026-09-16 | 2919 |  |  | 2026-08-27 | 2026-09-16 | 15d | 2026-01-27 | 2026-02-16 | 312d | 0d |  | PPC | CPT |  | Readiness Assessment | 638.33 | 5.0 | PPC | Readiness Assessments | Green | GREEN |  |  |  |
| 2922 | 1.12.4.5 | Produce Readiness Assessment Reports (Overall Report & Individual Participant Reports) |  | 15d | 2026-09-17 | 2026-10-07 | 2920, 2921 |  |  | 2026-09-17 | 2026-10-07 | 15d | 2026-02-17 | 2026-03-09 | 312d | 0d |  | PPC |  |  | Readiness Assessment | 659.33 | 5.0 | PPC | Readiness Assessments | Green | GREEN |  |  |  |
| 2923 | 1.12.4.6 | Readiness Assessment 8 - Ready to Accept New MPANs - Completed (incl. Readiness Assessment Report approval) | milestone | 0d | 2026-10-13 | 2026-10-13 | 2922FS+4d |  |  | 2026-10-13 | 2026-10-13 | 0d | 2026-03-13 | 2026-03-13 | 312d | 0d |  | CPT | PPC |  | Readiness Assessment | 685.71 | 5.0 | PPC | Readiness Assessments | Green | GREEN | T2-RA-0700 | PSG | T2 |
| 2924 | 1.12.5 | **Readiness Assessment 9 - Ready for New Settlement Timetable and CP5 Check** |  | 49d | 2027-04-12 | 2027-06-17 |  |  |  | 2027-04-12 | 2027-06-17 | 49d | 2026-09-29 | 2026-12-04 | 135d |  |  | N/A | N/A | D32 - RA10 Readiness Report | Readiness Assessment | M16 | 5.0 | N/A | Readiness Assessments |  |  |  |  |  |
| 2925 | 1.12.5.1 | Launch Readiness Assessment survey | milestone | 0d | 2027-04-12 | 2027-04-12 | 2852FS-60d |  |  | 2027-04-12 | 2027-04-12 | 0d | 2026-09-29 | 2026-09-29 | 135d | 0d |  | PPC |  |  | Readiness Assessment | 866.33 | 5.0 | PPC | Readiness Assessments | Green | GREEN |  |  |  |
| 2926 | 1.12.5.2 | PPs submit survey responses |  | 15d | 2027-04-12 | 2027-04-30 | 2925 |  |  | 2027-04-12 | 2027-04-30 | 15d | 2026-09-29 | 2026-10-19 | 135d | 0d |  | PP | PPC |  | Readiness Assessment | 866.33 | 5.0 | PPC | Readiness Assessments | Green | GREEN |  |  |  |
| 2927 | 1.12.5.3 | Analyse survey responses |  | 15d | 2027-05-03 | 2027-05-21 | 2926 |  |  | 2027-05-03 | 2027-05-21 | 15d | 2026-10-20 | 2026-11-09 | 135d | 0d |  | PPC | CPT |  | Readiness Assessment | 887.33 | 5.0 | PPC | Readiness Assessments | Green | GREEN |  |  |  |
| 2928 | 1.12.5.4 | Conduct deep-dive interviews (sample of PPs) |  | 15d | 2027-05-03 | 2027-05-21 | 2926 |  |  | 2027-05-03 | 2027-05-21 | 15d | 2026-10-20 | 2026-11-09 | 135d | 0d |  | PPC | CPT |  | Readiness Assessment | 887.33 | 5.0 | PPC | Readiness Assessments | Green | GREEN |  |  |  |
| 2929 | 1.12.5.5 | Produce Readiness Assessment Reports (Overall Report & Individual Participant Reports) |  | 15d | 2027-05-24 | 2027-06-11 | 2927, 2928 |  |  | 2027-05-24 | 2027-06-11 | 15d | 2026-11-10 | 2026-11-30 | 135d | 0d |  | PPC |  |  | Readiness Assessment | 908.33 | 5.0 | PPC | Readiness Assessments | Green | GREEN |  |  |  |
| 2930 | 1.12.5.6 | Readiness Assessment 9 - Readiness for New Settlement Timetable - Completed (incl. Readiness Assessment Report approval) | milestone | 0d | 2027-06-17 | 2027-06-17 | 2929FS+4d |  |  | 2027-06-17 | 2027-06-17 | 0d | 2026-12-04 | 2026-12-04 | 135d | 0d |  | CPT | PPC |  | Readiness Assessment | 932.71 | 5.0 | PPC | Readiness Assessments | Green | GREEN | T2-RA-0800 | PSG | T2 |
| 2931 | 1.12.6 | **Readiness Assessments - Tier 1 Milestones** |  | 517d | 2025-06-24 | 2027-06-17 |  |  |  | 2025-06-24 | 2027-06-17 | 799d | 2023-11-17 | 2026-12-04 | 135d |  |  | N/A | N/A |  | Readiness Assessment |  | 5.0 | N/A | Readiness Assessments |  |  |  |  |  |
| 2932 | 1.12.6.1 | Readiness Assessment 6 - Start of Migration - Completed (incl. Readiness Assessment Report approval) | milestone | 0d | 2025-06-24 | 2025-06-24 | 2909 |  |  | 2025-06-24 | 2025-06-24 | 0d | 2025-04-04 | 2025-04-04 | 652d |  | finish no earlier than 2025-04-04 | CPT | PPC |  | Readiness Assessment | 209.71 | 5.0 | PPC | Readiness Assessments | Green | GREEN | T2-RA-0500 | PSG | T2 |
| 2933 | 1.12.6.2 | Readiness Assessment 7 - Migration Checkpoint - Completed (incl. Readiness Assessment Report approval) | milestone | 0d | 2026-03-19 | 2026-03-19 | 2916 |  |  | 2026-03-19 | 2026-03-19 | 0d | 2025-10-09 | 2025-10-09 | 460d |  |  | CPT | PPC |  | Readiness Assessment | 477.71 | 5.0 | PPC | Readiness Assessments | Green | GREEN | T2-RA-0600 | PSG | T2 |
| 2934 | 1.12.6.3 | Readiness Assessment 8 - Ready to Accept New MPANs - Completed (incl. Readiness Assessment Report approval) | milestone | 0d | 2026-10-13 | 2026-10-13 | 2923 |  |  | 2026-10-13 | 2026-10-13 | 0d | 2026-03-13 | 2026-03-13 | 312d |  |  | CPT | PPC |  | Readiness Assessment | 685.71 | 5.0 | PPC | Readiness Assessments | Green | GREEN | T2-RA-0700 | PSG | T2 |
| 2935 | 1.12.6.4 | Readiness Assessment 9 - Readiness for New Settlement Timetable - Completed (incl. Readiness Assessment Report approval) | milestone | 0d | 2027-06-17 | 2027-06-17 | 2930 |  |  | 2027-06-17 | 2027-06-17 | 0d | 2026-12-04 | 2026-12-04 | 135d |  |  | CPT | PPC |  | Readiness Assessment | 932.71 | 5.0 | PPC | Readiness Assessments | Green | GREEN | T2-RA-0800 | PSG | T2 |
| 2936 | 1.13 | **CONTROL POINTS** |  | 1204d | 2022-11-10 A | 2027-06-23 |  | 51% | 591.8d | 2022-11-10 | 2027-06-23 | 1063d | 2022-11-10 | 2026-12-07 | 132d |  |  | N/A | N/A |  | Control Points |  |  | N/A | Control Points |  |  |  |  |  |
| 2937 | 1.13.1 | **Control Point 1 - Start of System Design, Build & Test** |  | 20d | 2022-11-10 A | 2022-12-07 A |  | 100% |  | 2022-11-10 | 2022-12-07 | 20d | 2022-11-10 | 2022-12-07 |  |  |  | N/A | N/A |  | Control Points |  | 5.0 | N/A | Control Points |  |  |  |  |  |
| 2938 | 1.13.1.1 | Control Point 1 Preparation (incl. Control Point Report development and review) |  | 15d | 2022-11-10 A | 2022-11-30 A | 2939SS-20d | 100% |  | 2022-11-10 | 2022-11-30 | 15d | 2022-11-10 | 2022-11-30 |  |  |  | CPT | PMO |  | Control Points |  | 5.0 | PMO | Control Points | Complete | COMPLETE |  |  |  |
| 2939 | 1.13.1.2 | Control Point 1 - Start of System Design, Build & Test (incl. Control Point Report approval) | milestone | 0d | 2022-12-07 A | 2022-12-07 A |  | 100% |  | 2022-12-07 | 2022-12-07 | 0d | 2022-12-07 | 2022-12-07 |  |  | must finish on 2022-12-07 | CPT | PMO | D24 - CP2 Approval | Control Points |  | 5.0 | PMO | Control Points | Complete | COMPLETE | T1-CP-1000 | PSG | T1 |
| 2940 | 1.13.2 | **Control Point 2 - Start of Integration & Test** |  | 20d | 2023-10-02 A | 2023-10-30 A |  | 100% |  | 2023-10-02 | 2023-10-30 | 20d | 2023-10-02 | 2023-10-30 |  |  |  | N/A | N/A |  | Control Points |  | 5.0 | N/A | Control Points |  |  |  |  |  |
| 2941 | 1.13.2.1 | Control Point 2 Preparation (incl. Control Point Report development and review) |  | 15d | 2023-10-02 A | 2023-10-20 A | 2942SS-20d | 100% |  | 2023-10-02 | 2023-10-20 | 15d | 2023-10-02 | 2023-10-20 |  |  |  | CPT | PMO |  | Control Points |  | 5.0 | PMO | Control Points | Complete | COMPLETE |  |  |  |
| 2942 | 1.13.2.2 | Control Point 2 - Start of Integration & Test (incl. Control Point Report approval) | milestone | 0d | 2023-10-30 A | 2023-10-30 A | 1432 | 100% |  | 2023-10-30 | 2023-10-30 | 0d | 2023-10-30 | 2023-10-30 |  |  |  | CPT | PMO | D24 - CP2 Approval | Control Points |  | 5.11 | PMO | Control Points | Complete | COMPLETE | T1-CP-2000 | PSG | T1 |

| ID | WBS | Task | Type | Duration | Start | Finish | Predecessors | Complete | Remaining | Baseline start | Baseline finish | Baseline duration | Baseline 1 start | Baseline 1 finish | Total slack | Free slack | Responsible | Involved | Future RAG | Text9 | Update Version | MHHS Resource Name | MHHS Programme Phase | Task Status | Sched Status | RAG | Milestone ID | Text29 | Tier |
| --- | --- | --- | --- | --- | --- | --- | --- | --- | --- | --- | --- | --- | --- | --- | --- | --- | --- | --- | --- | --- | --- | --- | --- | --- | --- | --- | --- | --- | --- |
| 2943 | 1.13.3 | **Control Point 3/4 - Readiness for Migration** |  | 20d | 2025-08-20 | 2025-09-17 |  |  |  | 2025-08-21 | 2025-09-18 | 20d | 2025-03-03 | 2025-03-28 | 592d |  | N/A | N/A | D26 - CP3 Approval | Control Points | 5.0 | N/A | Control Points |  |  |  |  |  |  |
| 2944 | 1.13.3.1 | Control Point 3/4 Preparation (incl. Control Point Report development and review) |  | 14d | 2025-08-20 | 2025-09-08 | 2945SS-20d |  |  | 2025-08-21 | 2025-09-09 | 14d | 2025-03-03 | 2025-03-21 | 598d |  | CPT | PMO |  | Control Points | 5.0 | PMO | Control Points | 266.33 | Green | GREEN |  |  |  |
| 2945 | 1.13.3.2 | Control Point 3/4 - Readiness for Migration (incl. Control Point Report approval) | milestone | 0d | 2025-09-17 | 2025-09-17 | 1712FS-5d |  |  | 2025-09-18 | 2025-09-18 | 0d | 2025-03-28 | 2025-03-28 | 592d | 0d | CPT | PMO |  | Control Points | 5.0 | PMO | Control Points | 294.33 | Green | GREEN | T1-CP-3000 | PSG | T1 |
| 2946 | 1.13.4 | **Control Point 5 - Cut Over to New Settlement Timetable** |  | 20d | 2027-05-26 | 2027-06-23 |  |  |  | 2027-05-26 | 2027-06-23 | 20d | 2026-11-10 | 2026-12-07 | 132d |  | N/A | N/A | D33 - Control Point 6 Approval | Control Points | 5.0 | N/A | Control Points | M16 |  |  |  |  |  |
| 2947 | 1.13.4.1 | Control Point 5 Preparation (incl. Control Point Report development and review) |  | 15d | 2027-05-26 | 2027-06-15 | 2948SS-20d |  |  | 2027-05-26 | 2027-06-15 | 15d | 2026-11-10 | 2026-11-30 | 137d |  | CPT | PP |  | Control Points | 5.0 | PMO | Control Points | 910.33 | Green | GREEN |  |  |  |
| 2948 | 1.13.4.2 | Control Point 5 - Cut Over to New Settlement Timetable (incl. Control Point Report approval) | milestone | 0d | 2027-06-23 | 2027-06-23 | 2852FS-8d |  |  | 2027-06-23 | 2027-06-23 | 0d | 2026-12-07 | 2026-12-07 | 132d | 0d | CPT | CPT | D33 - Control Point 6 Approval | Control Points | 5.0 | PMO | Control Points | 938.33 | Green | GREEN | T1-CP-4000 | PSG | T1 |
| 2949 | 1.13.5 | **Control Points - Tier 1 Milestones** |  | 1184d | 2022-12-07 A | 2027-06-23 |  |  | 1184d | 2022-12-07 | 2027-06-23 | 1043d | 2022-12-07 | 2026-12-07 | 132d |  | N/A | N/A |  | Control Points | 5.0 | N/A | Control Points |  |  |  |  |  |  |
| 2950 | 1.13.5.1 | Control Point 1 - Start of System Design, Build & Test (incl. Control Point Report approval) | milestone | 0d | 2022-12-07 A | 2022-12-07 A | 2939SS | 100% |  | 2022-12-07 | 2022-12-07 | 0d | 2022-12-07 | 2022-12-07 |  |  | CPT | PMO |  | Control Points | 5.0 | PMO | Control Points |  | Complete | COMPLETE | T1-CP-1000 | PSG | T1 |
| 2951 | 1.13.5.2 | Control Point 2 - Start of Integration & Test (incl. Control Point Report approval) | milestone | 0d | 2023-10-30 A | 2023-10-30 A | 2942SS | 100% |  | 2023-10-30 | 2023-10-30 | 0d | 2023-10-30 | 2023-10-30 |  |  | CPT | PMO | D24 - CP2 Approval | Control Points | 5.11 | PMO | Control Points |  | Complete | COMPLETE | T1-CP-2000 | PSG | T1 |
| 2952 | 1.13.5.3 | Control Point 3/4 - Readiness for Migration (incl. Control Point Report approval) | milestone | 0d | 2025-09-17 | 2025-09-17 | 2945SS |  |  | 2025-09-18 | 2025-09-18 | 0d | 2025-03-28 | 2025-03-28 | 592d |  | CPT | PMO |  | Control Points | 5.0 | PMO | Control Points | 294.33 | Green | GREEN | T1-CP-3000 | PSG | T1 |
| 2953 | 1.13.5.4 | Control Point 5 - Cut Over to New Settlement Timetable (incl. Control Point Report approval) | milestone | 0d | 2027-06-23 | 2027-06-23 | 2948SS |  |  | 2027-06-23 | 2027-06-23 | 0d | 2026-12-07 | 2026-12-07 | 132d |  | CPT | CPT | D33 - Control Point 6 Approval | Control Points | 5.0 | PMO | Control Points | 938.33 | Green | GREEN | T1-CP-4000 | PSG | T1 |
| 2954 | 1.14 | **MILESTONE RANGE CHECKPOINTS** |  | 1160d? | 2022-10-31 | 2027-04-12 |  |  |  | 2022-10-31 | 2027-04-12 | 436d | 2025-01-13 | 2026-09-15 | 184d |  | N/A | N/A |  | Milestone Range Checkpoints |  | N/A | Milestone Range Checkpoints |  |  |  |  |  |  |
| 2955 | 1.14.1 | **M10, M11, M12 and M13 milestone checkpoint** |  | 0d | 2025-07-30 | 2025-07-30 |  |  |  | 2025-07-31 | 2025-07-31 | 0d | 2025-01-13 | 2025-01-13 | 627d |  | N/A | N/A |  | Milestone Range Checkpoints | 5.0 | N/A | Milestone Range Checkpoints |  |  |  |  |  |  |
| 2956 | 1.14.1.1 | M10, M11, M12, and M13 milestone checkpoint - date approval | milestone | 0d | 2025-07-30 | 2025-07-30 | 2613FS-3mo, 2615FS-3mo, 2611FS-3mo, 1712FS-3mo |  |  | 2025-07-31 | 2025-07-31 | 0d | 2025-01-13 | 2025-01-13 | 627d |  | CPT | CPT |  | Milestone Range Checkpoints | 5.0 | PMO | Milestone Range Checkpoints | 245.33 | Green | GREEN | T2-MR-0100 | PSG | T2 |
| 2957 | 1.14.2 | **M14 milestone checkpoint** |  | 0d | 2026-08-06 | 2026-08-06 |  |  |  | 2026-08-06 | 2026-08-06 | 0d | 2025-12-23 | 2025-12-23 | 361d |  | N/A | N/A |  | Milestone Range Checkpoints | 5.0 | N/A | Milestone Range Checkpoints |  |  |  |  |  |  |
| 2958 | 1.14.2.1 | M14 milestone checkpoint - date approval | milestone | 0d | 2026-08-06 | 2026-08-06 | 2229FS-3mo |  |  | 2026-08-06 | 2026-08-06 | 0d | 2025-12-23 | 2025-12-23 | 361d |  | CPT | CPT |  | Milestone Range Checkpoints | 5.0 | PMO | Milestone Range Checkpoints | 617.33 | Green | GREEN | T2-MR-0200 | PSG | T2 |
| 2959 | 1.14.3 | **M15 milestone checkpoint** |  | 0d | 2027-02-15 | 2027-02-15 |  |  |  | 2027-02-15 | 2027-02-15 | 0d | 2026-07-14 | 2026-07-14 | 224d |  | N/A | N/A |  | Milestone Range Checkpoints | 5.0 | N/A | Milestone Range Checkpoints |  |  |  |  |  |  |
| 2960 | 1.14.3.1 | M15 milestone checkpoint - date approval | milestone | 0d | 2027-02-15 | 2027-02-15 | 2617FS-3mo |  |  | 2027-02-15 | 2027-02-15 | 0d | 2026-07-14 | 2026-07-14 | 224d |  | CPT | CPT |  | Milestone Range Checkpoints | 5.0 | PMO | Milestone Range Checkpoints | 810.33 | Green | GREEN | T2-MR-0300 | PSG | T2 |
| 2961 | 1.14.4 | **M16 milestone checkpoint** |  | 1160d? | 2022-10-31 | 2027-04-12 |  |  |  | 2022-10-31 | 2027-04-12 | 0d | 2026-09-15 | 2026-09-15 | 184d |  | N/A | N/A |  | Milestone Range Checkpoints | 5.0 | N/A | Milestone Range Checkpoints |  |  |  |  |  |  |
| 2962 | 1.14.4.1 | M16 milestone checkpoint - date approval | milestone | 0d | 2027-04-12 | 2027-04-12 | 2852FS-3mo |  |  | 2027-04-12 | 2027-04-12 | 0d | 2026-09-15 | 2026-09-15 | 184d |  | CPT | CPT |  | Milestone Range Checkpoints | 5.0 | PMO | Milestone Range Checkpoints | 866.33 | Green | GREEN | T2-MR-0400 | PSG | T2 |
