# Outline ELEXON Plan_kc

Schedule from MS Project, 2022-10-31 to 2148-12-31, status date 2024-10-21, A marks actual dates.

## Calendars

- Standard: Mon-Fri 08:00-12:00, 13:00-17:00; Sat-Sun off.

## Resources

| Resource |
| --- |
| PMO |
| SI |
| PPC |
| Lead Workstream |
| CPT |
| PP |
| SI Design |
| SI Design |
| SI Design |
| Design |
| SI DevOps |
| SI Test |
| PSG |
| DAG |
| TMAG |
| CCAG |
| Code drafters (SRO Design Team |
| Code Bodies) |
| CCAG PM |
| Programme Participants |
| Code drafters |
| CDWG |
| SRO Design Team |
| Code Bodies |
| Ofgem |
| Elexon resources TBC |
| LDP Programme Manager |
| SRO Client Programme Director |
| IPA |
| LDP |
| SRO |
| )) |
| ? |
| TBC |
| OOC |
| MHHSP |
| Adrian Page |
| Amy Clayton |
| Anand Kaveripatna |
| Berlinda Kugara |
| Cesar Lopes |
| Charlie Blanks |
| Chetan Ubale |
| Daniel Callender |
| Daniel Gee |
| David Hollinshead |
| Dean Bailey |
| Dominic Mooney |
| Elayaraja Jeyaraman |
| Georgi Rabotov |
| Giles Clayden |
| Helen Richardson |
| Ishti Bhatti |
| Jafer Shah |
| Jason Brogden |
| John Edmonds Bell |
| John Wiggins |
| Karthikeyan Ganesan |
| Kasimali Hajiyani |
| Kate Goodman |
| Keegan Moodley |
| Keith Clark |
| Keith Lawlor |
| kevin Davis |
| Kishore Konduru |
| Kyle Abraham |
| Mahjabeen Newaz |
| Martin Freeman |
| Matt Hall |
| Matthew Breen |
| Michael Inije |
| Michael Walton |
| Ming Li |
| Nathalia Revlien |
| Nick Sewell |
| Nigel Hunt |
| Oskar Cahill |
| Paul Pettitt |
| Rakhee Shah |
| Rebecca Farooq |
| Renu Rathor |
| Robert Short |
| Robert Topley |
| Saadia Sajjad |
| Sean Tuffy |
| Shaid Hussain |
| Sharmeen Shaikh |
| Simon Berry |
| Steve Bradford |
| Steve Weston |
| Taaran Suri |
| Waseem Mohammed |
| Zak Hussain |
| berli |
| SI Migration |
| v |
| Andrew Margan |
| Lee Cox |
| DIP SP |
| DIPS SP |
| DIPSP |
| Ian Smith |
| N/A |
| SIT Component Integration Testing 2 Preparation Complete (incl. approval of SI SIT Component Integration Test Readiness Report) |
| Nich |
| Nicola Farley |
| Warren Fulton |
| Richard Puddephatt |
| Matthew Bray |
| Programme |
| LDSOs |
| Ben Wickins |
| paul |
| LDSO |
| Simon chidwick |
| Stuart Scott |
| MHHS Programme |
| Claire Silk |
| Laura Kennedy |
| Rowan B |
| FD |
| MB |
| AM |
| Roger Robar |
| Laura Kennedy. |

## Schedule

| ID | WBS | Task | Type | Duration | Start | Finish | Complete | Remaining | Baseline start | Baseline finish | Baseline duration | Baseline 1 start | Baseline 1 finish | Total slack | Constraint | Baseline cost | Responsible | Involved | Update Version | MHHS Resource Name | Sched Status | RAG | Text9 | Task Status | Future RAG |
| --- | --- | --- | --- | --- | --- | --- | --- | --- | --- | --- | --- | --- | --- | --- | --- | --- | --- | --- | --- | --- | --- | --- | --- | --- | --- |
| 1 | 1 | **PROGRAMME PLAN.** |  | 1344d? | 2022-10-31 A | 2027-12-23 | 53% | 627.32d? | 2022-10-31 | 2027-12-23 | 1195d |  |  |  |  | -0 | N/A | N/A | 5.0 | N/A |  |  |  |  |  |
| 2 | 1.1 | MHHS Programme Start | milestone | 0d | 2022-10-31 A | 2022-10-31 A | 100% |  | 2022-10-31 | 2022-10-31 | 0d |  |  |  |  |  | N/A | N/A | 5.7 | N/A | Complete | COMPLETE |  |  |  |
| 3 | 1.2 | **PROGRAMME MANAGEMENT** |  | 1089d | 2022-10-31 A | 2026-12-31 | 44% | 609.27d | 2022-10-31 | 2026-12-31 | 1089d | 2022-10-31 | 2026-12-31 | 31828d |  |  | N/A | N/A | 5.0 | N/A |  |  |  |  |  |
| 4 | 1.2.1 | **Programme Management** |  | 1089d | 2022-10-31 A | 2026-12-31 | 43% | 616d | 2022-10-31 | 2026-12-31 | 1089d | 2022-10-31 | 2026-12-31 | 31828d |  |  | N/A | N/A | 5.0 | N/A |  |  | Programme Management | M10 |  |
| 5 | 1.2.1.1 | Sprint-based prioritisation planning and execution |  | 1089d | 2022-10-31 A | 2026-12-31 | 43% | 616d | 2022-10-31 | 2026-12-31 | 1089d | 2022-10-31 | 2026-12-31 | 31828d | finish no earlier than 2026-12-31 |  | PMO | CPT | 5.0 | N/A | Green | GREEN | Programme Management |  |  |
| 6 | 1.2.1.2 | Programme governance secretariat |  | 1089d | 2022-10-31 A | 2026-12-31 | 43% | 616d | 2022-10-31 | 2026-12-31 | 1089d | 2022-10-31 | 2026-12-31 | 31828d |  |  | PMO | CPT | 5.0 | N/A | Green | GREEN | Programme Management |  |  |
| 7 | 1.2.1.3 | RAID management and reporting |  | 1089d | 2022-10-31 A | 2026-12-31 | 43% | 616d | 2022-10-31 | 2026-12-31 | 1089d | 2022-10-31 | 2026-12-31 | 31828d |  |  | PMO | CPT | 5.0 | N/A | Green | GREEN | Programme Management |  |  |
| 8 | 1.2.1.4 | Tracking against Programme outcomes and KPIs |  | 1089d | 2022-10-31 A | 2026-12-31 | 43% | 616d | 2022-10-31 | 2026-12-31 | 1089d | 2022-10-31 | 2026-12-31 | 31828d |  |  | PMO | CPT | 5.0 | N/A | Green | GREEN | Programme Management |  |  |
| 9 | 1.2.1.5 | Change control and reporting |  | 1089d | 2022-10-31 A | 2026-12-31 | 43% | 616d | 2022-10-31 | 2026-12-31 | 1089d | 2022-10-31 | 2026-12-31 | 31828d |  |  | PMO | CPT | 5.0 | N/A | Green | GREEN | Programme Management |  |  |
| 10 | 1.2.1.6 | Ongoing identification of lessons learned relating to the PMO and implementation of improvements |  | 1089d | 2022-10-31 A | 2026-12-31 | 43% | 616d | 2022-10-31 | 2026-12-31 | 1089d | 2022-10-31 | 2026-12-31 | 31828d |  |  | PMO | CPT | 5.0 | N/A | Green | GREEN | Programme Management |  |  |
| 11 | 1.2.2 | **Programme Internal Assurance Reviews** |  | 1089d | 2022-10-31 A | 2026-12-31 | 43% | 616d | 2022-10-31 | 2026-12-31 | 1089d | 2022-10-31 | 2026-12-31 | 31828d |  |  | N/A | N/A | 5.0 | N/A |  |  | Programme Management | M9 | D18A - Quarterly Assurance Report |
| 12 | 1.2.2.1 | Programme Internal Assurance Reviews |  | 1089d | 2022-10-31 A | 2026-12-31 | 43% | 616d | 2022-10-31 | 2026-12-31 | 1089d | 2022-10-31 | 2026-12-31 | 31828d |  |  | CPT | PMO | 5.0 | N/A | Green | GREEN | Programme Management |  | D18A - Quarterly Assurance Report |
| 13 | 1.2.3 | **Engagement with PPs** |  | 1089d | 2022-10-31 A | 2026-12-31 | 43% | 615.89d | 2022-10-31 | 2026-12-31 | 1089d | 2022-10-31 | 2026-12-31 | 31828d |  |  | N/A | N/A | 5.0 | N/A |  |  | Programme Management | M5,M6 |  |
| 14 | 1.2.3.1 | Ongoing PP liaison activities |  | 1089d | 2022-10-31 A | 2026-12-31 | 43% | 616d | 2022-10-31 | 2026-12-31 | 1089d | 2022-10-31 | 2026-12-31 | 31828d |  |  | PPC | CPT | 5.0 | N/A | Green | GREEN | Programme Management |  |  |
| 15 | 1.2.3.2 | Milestone and Control Point objective setting |  | 1089d | 2022-10-31 A | 2026-12-31 | 43% | 616d | 2022-10-31 | 2026-12-31 | 1089d | 2022-10-31 | 2026-12-31 | 31828d |  |  | PPC | CPT | 5.0 | N/A | Green | GREEN | Programme Management |  |  |
| 16 | 1.2.3.3 | Reporting |  | 1089d | 2022-10-31 A | 2026-12-31 | 43% | 616d | 2022-10-31 | 2026-12-31 | 1089d | 2022-10-31 | 2026-12-31 | 31828d |  |  | PPC |  | 5.0 | N/A | Green | GREEN | Programme Management |  |  |
| 17 | 1.2.3.4 | **PP Engagement Events** |  | 1089d | 2022-10-31 A | 2026-12-31 | 43% | 616d | 2022-10-31 | 2026-12-31 | 1089d | 2022-10-31 | 2026-12-31 | 31828d |  |  | N/A | N/A | 5.0 | N/A |  |  | Programme Management |  |  |
| 18 | 1.2.3.4.1 | Bilateral meetings |  | 1089d | 2022-10-31 A | 2026-12-31 | 43% | 616d | 2022-10-31 | 2026-12-31 | 1089d | 2022-10-31 | 2026-12-31 | 31828d |  |  | PPC | CPT | 5.0 | N/A | Green | GREEN | Programme Management |  |  |
| 19 | 1.2.3.4.2 | Monthly webinars |  | 1089d | 2022-10-31 A | 2026-12-31 | 43% | 616d | 2022-10-31 | 2026-12-31 | 1089d | 2022-10-31 | 2026-12-31 | 31828d |  |  | PPC | CPT | 5.0 | N/A | Green | GREEN | Programme Management |  |  |
| 20 | 1.2.3.4.3 | Open days |  | 1089d | 2022-10-31 A | 2026-12-31 | 43% | 616d | 2022-10-31 | 2026-12-31 | 1089d | 2022-10-31 | 2026-12-31 | 31828d |  |  | PPC | CPT | 5.0 | N/A | Green | GREEN | Programme Management |  |  |
| 21 | 1.2.3.5 | **PP Communications** |  | 1088d | 2022-10-31 A | 2026-12-30 | 43% | 615d | 2022-10-31 | 2026-12-30 | 1088d | 2022-10-31 | 2026-12-30 | 31829d |  |  | N/A | N/A | 5.0 | N/A |  |  | Programme Management |  |  |
| 22 | 1.2.3.5.1 | The Clock updates (weekly) |  | 1088d | 2022-10-31 A | 2026-12-30 | 43% | 615d | 2022-10-31 | 2026-12-30 | 1088d | 2022-10-31 | 2026-12-30 | 31829d |  |  | PPC |  | 5.0 | N/A | Green | GREEN | Programme Management |  |  |
| 23 | 1.2.3.5.2 | Maintain and update content on public-facing Portal (and ongoing feedback reviews to identify and implement Portal improvements) |  | 1088d | 2022-10-31 A | 2026-12-30 | 43% | 615d | 2022-10-31 | 2026-12-30 | 1088d | 2022-10-31 | 2026-12-30 | 31829d |  |  | PPC |  | 5.0 | N/A | Green | GREEN | Programme Management |  |  |
| 24 | 1.2.4 | **Code Change Support / Other Programme Alignment** |  | 1089d | 2022-10-31 A | 2026-12-31 | 43% | 616d | 2022-10-31 | 2026-12-31 | 1089d | 2022-10-31 | 2026-12-31 | 31828d |  |  | N/A | N/A | 5.0 | N/A |  |  | Programme Management | M6 | D17 - Code Change Report & Recommendations |
| 25 | 1.2.4.1 | Support DCC/BEIS on SEC change |  | 1089d | 2022-10-31 A | 2026-12-31 | 43% | 616d | 2022-10-31 | 2026-12-31 | 1089d | 2022-10-31 | 2026-12-31 | 31828d |  |  | CPT |  | 5.0 | N/A | Green | GREEN | Programme Management |  |  |
| 26 | 1.2.4.2 | Support on Smart Meters Act changes |  | 1089d | 2022-10-31 A | 2026-12-31 | 43% | 616d | 2022-10-31 | 2026-12-31 | 1089d | 2022-10-31 | 2026-12-31 | 31828d |  |  | CPT |  | 5.0 | N/A | Green | GREEN | Programme Management |  |  |
| 27 | 1.2.4.3 | Support DCC/RECCo on CSS change |  | 1089d | 2022-10-31 A | 2026-12-31 | 43% | 616d | 2022-10-31 | 2026-12-31 | 1089d | 2022-10-31 | 2026-12-31 | 31828d |  |  | CPT |  | 5.0 | N/A | Green | GREEN | Programme Management |  |  |
| 28 | 1.2.4.4 | Support Elexon on BSC change |  | 1089d | 2022-10-31 A | 2026-12-31 | 43% | 616d | 2022-10-31 | 2026-12-31 | 1089d | 2022-10-31 | 2026-12-31 | 31828d |  |  | CPT |  | 5.0 | N/A | Green | GREEN | Programme Management |  |  |
| 29 | 1.2.4.5 | Support code change inside & outside CCIAG |  | 1089d | 2022-10-31 A | 2026-12-31 | 43% | 616d | 2022-10-31 | 2026-12-31 | 1089d | 2022-10-31 | 2026-12-31 | 31828d |  |  | CPT |  | 5.0 | N/A | Green | GREEN | Programme Management |  |  |
| 30 | 1.2.4.6 | Support code change inside & outside CCAG |  | 1089d | 2022-10-31 A | 2026-12-31 | 43% | 616d | 2022-10-31 | 2026-12-31 | 1089d | 2022-10-31 | 2026-12-31 | 31828d |  |  | CPT |  | 5.0 | N/A | Green | GREEN | Programme Management |  |  |

| ID | WBS | Task | Type | Duration | Start | Finish | Predecessors | Complete | Remaining | Baseline start | Baseline finish | Baseline duration | Baseline 1 start | Baseline 1 finish | Total slack | Constraint | Baseline cost | Responsible | Involved | Text9 | Task Status | Update Version | MHHS Resource Name | Sched Status | RAG | Future RAG | MHHS Programme Phase | Text29 | Artefact ID | Milestone ID | Tier |
| --- | --- | --- | --- | --- | --- | --- | --- | --- | --- | --- | --- | --- | --- | --- | --- | --- | --- | --- | --- | --- | --- | --- | --- | --- | --- | --- | --- | --- | --- | --- | --- |
| 31 | 1.2.5 | **Programme Replan Baseline** |  | 163d | 2022-10-31 A | 2023-06-14 A |  | 100% |  | 2022-10-31 | 2023-06-14 | 163d | 2022-10-31 | 2023-06-14 |  |  |  | N/A | N/A | Programme Management | M5+ | 5.0 | N/A |  |  |  |  |  |  |  |  |
| 32 | 1.2.5.1 | Round 3 consultation preparation |  | 32d | 2022-10-31 A | 2022-12-13 A |  | 100% |  | 2022-10-31 | 2022-12-13 | 32d | 2022-10-31 | 2022-12-13 |  |  |  | PMO | CPT | Programme Management |  | 5.0 | N/A | Complete | COMPLETE |  |  |  |  |  |  |
| 33 | 1.2.5.2 | PSG decision to launch Round 3 consultation | milestone | 0d | 2022-12-07 A | 2022-12-07 A | 32FS-5d | 100% |  | 2022-12-07 | 2022-12-07 | 0d | 2022-12-07 | 2022-12-07 |  |  |  | PMO | PPC | Programme Management |  | 5.0 | N/A | Complete | COMPLETE |  |  |  |  |  |  |
| 34 | 1.2.5.3 | Round 3 consultation (incl. walkthroughs and Q&A) |  | 35d | 2022-12-14 A | 2023-01-31 A | 33FS+5d | 100% |  | 2022-12-14 | 2023-01-31 | 35d | 2022-12-14 | 2023-01-31 |  |  |  | PP | PMO, PPC,IPA | Programme Management |  | 5.0 | N/A | Complete | COMPLETE |  |  |  |  |  |  |
| 35 | 1.2.5.4 | Review and uplift of foundational testing documents to align with replan approach |  | 92d | 2022-12-14 A | 2023-04-20 A | 34SS | 100% |  | 2022-12-14 | 2023-04-20 | 92d | 2022-12-14 | 2023-04-20 |  |  |  | SI Test | CPT | Programme Management |  | 5.0 | N/A | Complete | COMPLETE |  |  |  |  |  |  |
| 36 | 1.2.5.5 | Round 3 consultation responses analysis (incl. identification of SIT volunteers) |  | 10d | 2023-02-01 A | 2023-02-14 A | 34 | 100% |  | 2023-02-01 | 2023-02-14 | 10d | 2023-02-01 | 2023-02-14 |  |  |  | PMO | CPT | Programme Management |  | 5.0 | N/A | Complete | COMPLETE |  |  |  |  |  |  |
| 37 | 1.2.5.6 | Replan re-drafting and supporting artefact updates (incl. engagement with Ofgem) |  | 26d | 2023-02-15 A | 2023-03-22 A | 36 | 100% |  | 2023-02-15 | 2023-03-22 | 26d | 2023-02-15 | 2023-03-22 |  |  |  | PMO | CPT,IPA,Ofgem | Programme Management |  | 5.0 | N/A | Complete | COMPLETE |  |  |  |  |  |  |
| 38 | 1.2.5.7 | Draft Replan Change Request |  | 31d | 2023-02-15 A | 2023-03-29 A | 36 | 100% |  | 2023-02-15 | 2023-03-29 | 31d | 2023-02-15 | 2023-03-29 |  |  |  | PMO | CPT | Programme Management |  | 5.0 | N/A | Complete | COMPLETE |  |  |  |  |  |  |
| 39 | 1.2.5.8 | PSG decision to issue CR for industry impact assessment | milestone | 0d | 2023-04-05 A | 2023-04-05 A | 38FS+5d | 100% |  | 2023-04-05 | 2023-04-05 | 0d | 2023-04-05 | 2023-04-05 |  |  |  | PMO | CPT | Programme Management |  | 5.0 | N/A | Complete | COMPLETE |  |  |  |  |  |  |
| 40 | 1.2.5.9 | Industry impact assessment |  | 10d | 2023-04-06 A | 2023-04-19 A | 39 | 100% |  | 2023-04-06 | 2023-04-19 | 10d | 2023-04-06 | 2023-04-19 |  |  |  | PP | PMO,PPC | Programme Management |  | 5.0 | N/A | Complete | COMPLETE |  |  |  |  |  |  |
| 41 | 1.2.5.10 | Replan playbacks (to assist PPs in impact assessment) |  | 5d | 2023-04-11 A | 2023-04-17 A | 40SS+3d | 100% |  | 2023-04-11 | 2023-04-17 | 5d | 2023-04-11 | 2023-04-17 |  |  |  | CPT | PPC,PP | Programme Management |  | 5.0 | N/A | Complete | COMPLETE |  |  |  |  |  |  |
| 42 | 1.2.5.11 | Industry impact assessment responses analysis |  | 5d | 2023-04-20 A | 2023-04-26 A | 40 | 100% |  | 2023-04-20 | 2023-04-26 | 5d | 2023-04-20 | 2023-04-26 |  |  |  | PMO | CPT | Programme Management |  | 5.0 | N/A | Complete | COMPLETE |  |  |  |  |  |  |
| 43 | 1.2.5.12 | Extraordinary PSG decision to agree baseline recommendation | milestone | 0d | 2023-05-03 A | 2023-05-03 A | 42FS+5d | 100% |  | 2023-05-03 | 2023-05-03 | 0d | 2023-05-03 | 2023-05-03 |  |  |  | CPT | PMO,PP | Programme Management |  | 5.0 | N/A | Complete | COMPLETE |  |  |  |  |  |  |
| 44 | 1.2.5.13 | Programme Replan playbacks and drop-in sessions |  | 5d | 2023-06-08 A | 2023-06-14 A |  | 100% |  | 2023-06-08 | 2023-06-14 | 5d | 2023-06-08 | 2023-06-14 |  |  |  | PMO | PPC, PP | Programme Management |  | 5.0 | N/A | Complete | COMPLETE |  |  |  |  |  |  |
| 45 | 1.3 | **DESIGN, BUILD & TEST (PIT)** |  | 1221d? | 2022-10-31 A | 2027-07-05 |  | 79% | 255.32d? | 2022-10-31 | 2027-07-05 | 1101d | 2022-10-31 | 2027-01-18 | 31696d |  | -0 | N/A | N/A | DBT |  |  | N/A |  |  | 1 May 2022 - 31 Jul 2023 | Design, Build & Test (PIT) | DAG |  |  |  |
| 46 | 1.3.1 | **Design Baseline & Enduring PP Support** |  | 1101d | 2022-10-31 A | 2027-01-18 |  | 71% | 319.69d | 2022-10-31 | 2027-01-18 | 1101d | 2022-10-31 | 2027-01-18 | 31816d |  | -0 | N/A | N/A | DBT |  | 5.0 | N/A |  |  |  | Design, Build & Test (PIT) |  |  |  |  |
| 47 | 1.3.1.1 | Physical design baselined (M5) | milestone | 0d | 2022-10-31 A | 2022-10-31 A |  | 100% |  | 2022-10-31 | 2022-10-31 | 0d | 2022-10-31 | 2022-10-31 |  |  |  | SRO Design | SI Design,PP,IPA | DBT |  | 5.0 | Paul Pettitt | Complete | COMPLETE |  | Design, Build & Test (PIT) | PSG | MHHS-ART001 | T1-DB-1000 | T1 |
| 48 | 1.3.1.2 | **M5 Design Work-Off Plan Implementation & Approval** |  | 79d | 2022-10-31 A | 2023-02-16 A |  | 100% |  | 2022-10-31 | 2023-02-16 | 79d | 2022-10-31 | 2023-02-16 |  |  |  | N/A | N/A | DBT |  | 5.0 | N/A |  |  |  | Design, Build & Test (PIT) |  |  |  |  |
| 49 | 1.3.1.2.1 | Implementation of M5 design Work-Off Plan |  | 74d | 2022-10-31 A | 2023-02-09 A | 47 | 100% |  | 2022-10-31 | 2023-02-09 | 74d | 2022-10-31 | 2023-02-09 |  |  |  | SI Design | PP | DBT |  | 5.0 | Paul Pettitt | Complete | COMPLETE |  | Design, Build & Test (PIT) |  |  |  |  |
| 50 | 1.3.1.2.2 | M5 design Work-Off Plan completion approved | milestone | 0d | 2023-02-16 A | 2023-02-16 A | 49FS+5d | 100% |  | 2023-02-16 | 2023-02-16 | 0d | 2023-02-16 | 2023-02-16 |  |  |  | SI Design | PP | DBT |  | 5.0 | Paul Pettitt | Complete | COMPLETE |  | Design, Build & Test (PIT) | DAG |  | T3-DB-0014 | T3 |
| 51 | 1.3.1.3 | **Enduring PP Design Support** |  | 1089d | 2022-10-31 A | 2026-12-31 A |  | 100% |  | 2022-10-31 | 2026-12-31 | 1089d | 2022-10-31 | 2026-12-31 |  |  |  | N/A | N/A | DBT |  | 5.0 | N/A |  |  |  | Design, Build & Test (PIT) |  |  |  |  |
| 52 | 1.3.1.3.1 | Design playbacks and drop-in sessions |  | 45d | 2022-10-31 A | 2022-12-30 A | 47 | 100% |  | 2022-10-31 | 2022-12-30 | 45d | 2022-10-31 | 2022-12-30 |  |  |  | SI Design | PMO,PPC, SRO Design | DBT |  | 5.0 | Paul Pettitt | Complete | COMPLETE |  | Design, Build & Test (PIT) |  |  |  |  |
| 53 | 1.3.1.3.2 | Support participants on E2E MHHS Design |  | 1089d | 2022-10-31 A | 2026-12-31 A | 47 | 100% |  | 2022-10-31 | 2026-12-31 | 1089d | 2022-10-31 | 2026-12-31 |  |  |  | SI Design | PP | DBT |  | 5.0 | Paul Pettitt | Complete | COMPLETE |  | Design, Build & Test (PIT) |  |  |  |  |
| 54 | 1.3.1.3.3 | DIP Onboarding Support |  | 70d | 2022-11-14 A | 2023-02-17 A |  | 100% |  | 2022-11-14 | 2023-02-17 | 70d | 2022-11-14 | 2023-02-17 |  | must start on 2022-11-14 |  | SI Design | SRO Design | DBT |  | 5.0 | Paul Pettitt | Complete | COMPLETE |  | Design, Build & Test (PIT) |  |  |  |  |
| 55 | 1.3.1.3.4 | iServer Launch | milestone | 0d | 2023-02-16 A | 2023-02-16 A | 50 | 100% |  | 2023-02-16 | 2023-02-16 | 0d | 2023-02-16 | 2023-02-16 |  |  |  | SI Design | PP | DBT |  | 5.0 | Paul Pettitt | Complete | COMPLETE |  | Design, Build & Test (PIT) |  |  |  |  |

| ID | WBS | Task | Type | Duration | Start | Finish | Predecessors | Complete | Remaining | Baseline start | Baseline finish | Baseline duration | Baseline 1 start | Baseline 1 finish | Total slack | Constraint | Baseline cost | Responsible | Involved | Text9 | Update Version | MHHS Resource Name | MHHS Programme Phase | Sched Status | RAG | Milestone ID | Text29 | Tier |
| --- | --- | --- | --- | --- | --- | --- | --- | --- | --- | --- | --- | --- | --- | --- | --- | --- | --- | --- | --- | --- | --- | --- | --- | --- | --- | --- | --- | --- |
| 56 | 1.3.1.4 | **Establish Design Change Management Processes** |  | 1101d | 2022-10-31 A | 2027-01-18 |  | 36% | 706.22d | 2022-10-31 | 2027-01-18 | 1101d | 2022-10-31 | 2027-01-18 | 31816d |  |  | N/A | N/A | DBT | 5.0 | N/A | Design, Build & Test (PIT) |  |  |  |  |  |
| 57 | 1.3.1.4.1 | Internal review of internal change management processes |  | 35d | 2022-10-31 A | 2022-12-16 A |  | 100% |  | 2022-10-31 | 2022-12-16 | 35d | 2022-10-31 | 2022-12-16 |  |  |  | SRO | SI Design | DBT | 5.0 | Paul Pettitt | Design, Build & Test (PIT) | Complete | COMPLETE |  |  |  |
| 58 | 1.3.1.4.2 | SRO approval of internal change management processes | milestone | 0d | 2022-12-16 A | 2022-12-16 A | 57FF | 100% |  | 2022-12-16 | 2022-12-16 | 0d | 2022-12-16 | 2022-12-16 |  |  |  | SRO | SI Design | DBT | 5.0 | Paul Pettitt | Design, Build & Test (PIT) | Complete | COMPLETE |  |  |  |
| 59 | 1.3.1.4.3 | Change Process Webinar | milestone | 0d | 2023-01-16 A | 2023-01-16 A |  | 100% |  | 2023-01-16 | 2023-01-16 | 0d | 2023-01-16 | 2023-01-16 |  | must start on 2023-01-16 |  | SI Design | PP | DBT | 5.0 | Paul Pettitt | Design, Build & Test (PIT) | Complete | COMPLETE |  |  |  |
| 60 | 1.3.1.4.4 | Enduring change management process approved | milestone | 0d | 2023-02-16 A | 2023-02-16 A | 50FF | 100% |  | 2023-02-16 | 2023-02-16 | 0d | 2023-02-16 | 2023-02-16 |  |  |  | SI Design | PP | DBT | 5.0 | Paul Pettitt | Design, Build & Test (PIT) | Complete | COMPLETE | T3-DB-0016 | DAG | T3 |
| 61 | 1.3.1.4.5 | Maintain E2E MHHS Design (post-M5 design change management processes operational) |  | 1022d | 2023-02-17 A | 2027-01-18 | 60 | 34% | 678d | 2023-02-17 | 2027-01-18 | 1022d | 2023-02-17 | 2027-01-18 | 31816d |  |  | SI Design | PP | DBT | 5.0 | Paul Pettitt | Design, Build & Test (PIT) | Green | GREEN |  |  |  |
| 62 | 1.3.1.5 | **Design Authority Mobilisation** |  | 29d | 2022-12-14 A | 2023-01-23 A |  | 100% |  | 2022-12-14 | 2023-01-23 | 29d | 2022-12-14 | 2023-01-23 |  |  |  | N/A | N/A | DBT | 5.0 | N/A | Design, Build & Test (PIT) |  |  |  |  |  |
| 63 | 1.3.1.5.1 | Design Authority ToR approved | milestone | 0d | 2022-12-14 A | 2022-12-14 A |  | 100% |  | 2022-12-14 | 2022-12-14 | 0d | 2022-12-14 | 2022-12-14 |  | must start on 2022-12-14 |  | SI Design | PP | DBT | 5.0 | Paul Pettitt | Design, Build & Test (PIT) | Complete | COMPLETE | T3-DB-0010 | DAG | T3 |
| 64 | 1.3.1.5.2 | Inaugural Design Authority | milestone | 0d | 2023-01-23 A | 2023-01-23 A | 63FS+29d | 100% |  | 2023-01-23 | 2023-01-23 | 0d | 2023-01-23 | 2023-01-23 |  |  |  | SI Design | PP | DBT | 5.0 | Paul Pettitt | Design, Build & Test (PIT) | Complete | COMPLETE |  |  |  |
| 65 | 1.3.1.6 | **Network Operation Services Adaptor Procurement** |  | 0d | 2023-05-23 A | 2023-05-23 A |  | 100% |  | 2023-05-23 | 2023-05-23 | 0d | 2023-02-01 | 2025-03-14 |  |  | -0 | N/A | N/A | DBT | 5.0 | N/A | Design, Build & Test (PIT) |  |  |  |  |  |
| 66 | 1.3.1.6.1 | All SIT LDSOs have procured their adapter providers | milestone | 0d | 2023-05-23 A | 2023-05-23 A | 594SS | 100% |  | 2023-05-23 | 2023-05-23 | 0d | 2023-05-23 | 2023-05-23 |  |  |  | SI Design | PP | DBT | 5.0 | Paul Pettitt | Design, Build & Test (PIT) | Complete | COMPLETE | T3-DB-0020 | DAG | T3 |
| 67 | 1.3.2 | **PP Mobilisation** |  | 67d | 2022-10-31 A | 2023-01-31 A |  | 100% |  | 2022-10-31 | 2023-01-31 | 67d | 2022-10-31 | 2023-01-31 |  |  |  | N/A | N/A | DBT | 5.0 | N/A | Design, Build & Test (PIT) |  |  |  |  |  |
| 68 | 1.3.2.1 | Set up governance |  | 67d | 2022-10-31 A | 2023-01-31 A |  | 100% |  | 2022-10-31 | 2023-01-31 | 67d | 2022-10-31 | 2023-01-31 |  |  |  | PP |  | DBT | 5.0 | PP | Design, Build & Test (PIT) | Complete | COMPLETE |  |  |  |
| 69 | 1.3.2.2 | Set up reporting |  | 67d | 2022-10-31 A | 2023-01-31 A |  | 100% |  | 2022-10-31 | 2023-01-31 | 67d | 2022-10-31 | 2023-01-31 |  |  |  | PP |  | DBT | 5.0 | PP | Design, Build & Test (PIT) | Complete | COMPLETE |  |  |  |
| 70 | 1.3.2.3 | Obtain funding |  | 67d | 2022-10-31 A | 2023-01-31 A |  | 100% |  | 2022-10-31 | 2023-01-31 | 67d | 2022-10-31 | 2023-01-31 |  |  |  | PP |  | DBT | 5.0 | PP | Design, Build & Test (PIT) | Complete | COMPLETE |  |  |  |
| 71 | 1.3.2.4 | Earmark resources |  | 67d | 2022-10-31 A | 2023-01-31 A |  | 100% |  | 2022-10-31 | 2023-01-31 | 67d | 2022-10-31 | 2023-01-31 |  |  |  | PP |  | DBT | 5.0 | PP | Design, Build & Test (PIT) | Complete | COMPLETE |  |  |  |
| 72 | 1.3.2.5 | Mobilise initial team |  | 67d | 2022-10-31 A | 2023-01-31 A |  | 100% |  | 2022-10-31 | 2023-01-31 | 67d | 2022-10-31 | 2023-01-31 |  |  |  | PP |  | DBT | 5.0 | PP | Design, Build & Test (PIT) | Complete | COMPLETE |  |  |  |
| 73 | 1.3.3 | **PIT Stub Specification and Delivery** |  | 435d | 2022-10-31 A | 2024-06-28 A |  | 100% |  | 2022-10-31 | 2024-06-28 | 430d | 2022-10-31 | 2023-05-31 |  |  | -0 | N/A | N/A | DBT | 5.0 | N/A | Design, Build & Test (PIT) |  |  |  |  |  |
| 74 | 1.3.3.1 | **DIP Simulator** |  | 108d | 2022-10-31 A | 2023-03-29 A |  | 100% |  | 2022-10-31 | 2023-03-29 | 108d | 2022-10-31 | 2023-03-29 |  |  |  | N/A | N/A | DBT | 5.0 | N/A | Design, Build & Test (PIT) |  |  |  |  |  |
| 75 | 1.3.3.1.1 | Build & Test |  | 95d | 2022-10-31 A | 2023-03-10 A | 47 | 100% |  | 2022-10-31 | 2023-03-10 | 95d | 2022-10-31 | 2023-03-10 |  |  |  | SI DevOps |  | DBT | 5.0 | Rebecca Farooq | Design, Build & Test (PIT) | Complete | COMPLETE |  |  |  |
| 76 | 1.3.3.1.2 | UAT |  | 85d | 2022-11-14 A | 2023-03-10 A | 75SS+10d | 100% |  | 2022-11-14 | 2023-03-10 | 85d | 2022-11-14 | 2023-03-10 |  |  |  | SI Test |  | DBT | 5.0 | Rebecca Farooq | Design, Build & Test (PIT) | Complete | COMPLETE |  |  |  |
| 77 | 1.3.3.1.3 | Beta test |  | 95d | 2022-10-31 A | 2023-03-10 A | 75SS | 100% |  | 2022-10-31 | 2023-03-10 | 95d | 2022-10-31 | 2023-03-10 |  |  |  | PP | SI Test | DBT | 5.0 | Rebecca Farooq | Design, Build & Test (PIT) | Complete | COMPLETE |  |  |  |
| 78 | 1.3.3.1.4 | Prepare for release |  | 18d | 2023-03-06 A | 2023-03-29 A | 77FS-5d | 100% |  | 2023-03-06 | 2023-03-29 | 18d | 2023-03-06 | 2023-03-29 |  |  |  | SI DevOps |  | DBT | 5.0 | Rebecca Farooq | Design, Build & Test (PIT) | Complete | COMPLETE |  |  |  |
| 79 | 1.3.3.1.5 | DIP Simulator released | milestone | 0d | 2023-03-29 A | 2023-03-29 A | 78FF | 100% |  | 2023-03-29 | 2023-03-29 | 0d | 2023-03-29 | 2023-03-29 |  | start no earlier than 2023-01-30 |  | SI DevOps |  | DBT | 5.0 | Rebecca Farooq | Design, Build & Test (PIT) | Complete | COMPLETE | T3-DB-0018 | SITAG | T3 |

| ID | WBS | Task | Type | Duration | Start | Finish | Predecessors | Complete | Remaining | Baseline start | Baseline finish | Baseline duration | Baseline 1 start | Baseline 1 finish | Total slack | Constraint | Baseline cost | Responsible | Involved | Text9 | Update Version | MHHS Resource Name | MHHS Programme Phase | Sched Status | RAG | Milestone ID | Text29 | Tier |
| --- | --- | --- | --- | --- | --- | --- | --- | --- | --- | --- | --- | --- | --- | --- | --- | --- | --- | --- | --- | --- | --- | --- | --- | --- | --- | --- | --- | --- |
| 80 | 1.3.3.2 | **DIP Simulator Uplifts** |  | 257d | 2023-07-06 A | 2024-06-28 A |  | 100% |  | 2023-07-06 | 2024-06-28 | 252d |  |  |  |  | -0 | N/A | N/A | DBT | 5.1 | N/A | Design, Build & Test (PIT) |  |  |  |  |  |
| 81 | 1.3.3.2.1 | DIP Simulator uplifted to align with design releases - design/build/test |  | 27d | 2023-07-06 A | 2023-08-11 A | 117 | 100% |  | 2023-07-06 | 2023-08-11 | 27d |  |  |  |  |  | SI DevOps |  | DBT | 5.1 | Rebecca Farooq | Design, Build & Test (PIT) | Complete | COMPLETE |  |  |  |
| 82 | 1.3.3.2.2 | DIP Simulator uplifted to align with Interim Release 2 | milestone | 0d | 2023-08-11 A | 2023-08-11 A | 81 | 100% |  | 2023-08-11 | 2023-08-11 | 0d |  |  |  |  |  | SI DevOps |  | DBT | 5.1 | Rebecca Farooq | Design, Build & Test (PIT) | Complete | COMPLETE | T3-DB-0035 | SITAG | T3 |
| 83 | 1.3.3.2.3 | DIP Simulator uplifted to align with design releases - design/build/test |  | 20d | 2023-10-09 A | 2023-11-03 A | 126FS+2d | 100% |  | 2023-10-09 | 2023-11-03 | 20d |  |  |  |  |  | SI DevOps |  | DBT | 5.3 | Rebecca Farooq | Design, Build & Test (PIT) | Complete | COMPLETE |  |  |  |
| 84 | 1.3.3.2.4 | DIP Simulator uplifted to align with Interim Release 5 | milestone | 0d | 2023-11-03 A | 2023-11-03 A | 83 | 100% |  | 2023-11-03 | 2023-11-03 | 0d |  |  |  |  |  | SI DevOps |  | DBT | 5.11 | Rebecca Farooq | Design, Build & Test (PIT) | Complete | COMPLETE | T3-DB-0039 | SITAG | T3 |
| 85 | 1.3.3.2.5 | DIP Simulator uplifted to align with design releases - design/build/test |  | 37d | 2024-02-01 A | 2024-03-22 A | 134 | 100% |  | 2024-02-01 | 2024-03-22 | 37d |  |  |  |  |  | SI DevOps | PP,SRO,Testing | DBT | 5.14 | Matthew Bray | Design, Build & Test (PIT) | Complete | COMPLETE |  |  |  |
| 86 | 1.3.3.2.6 | DIP Simulator uplifted to align with Interim Release 7 | milestone | 0d | 2024-03-22 A | 2024-03-22 A | 85 | 100% |  | 2024-03-22 | 2024-03-22 | 0d |  |  |  |  |  | SI DevOps | PP,SRO,Testing | DBT | 5.14 | Matthew Bray | Design, Build & Test (PIT) | Complete | COMPLETE | T3-DB-0182 | SITAG | T3 |
| 87 | 1.3.3.2.7 | DIP Simulator uplifted to align with design releases - design/build/test |  | 57d | 2024-04-04 A | 2024-06-21 A | 138 | 100% |  | 2024-04-04 | 2024-06-21 | 57d |  |  |  |  |  | SI DevOps | PP,SRO,Testing | DBT | 5.14 | Matthew Bray | Design, Build & Test (PIT) | Complete | COMPLETE |  |  |  |
| 88 | 1.3.3.2.8 | DIP Simulator uplifted to align with Interim Release 8 | milestone | 0d | 2024-06-28 A | 2024-06-28 A | 87FS+5d | 100% |  | 2024-06-28 | 2024-06-28 | 0d |  |  |  |  |  | SI DevOps | PP,SRO,Testing | DBT | 5.28 | Matthew Bray | Design, Build & Test (PIT) | Complete | COMPLETE | T3-DB-0183 | SITAG | T3 |
| 89 | 1.3.3.3 | **Data Generator** |  | 130d | 2022-12-01 A | 2023-05-31 A |  | 100% |  | 2022-12-01 | 2023-05-31 | 130d | 2022-12-01 | 2023-05-31 |  |  |  | N/A | N/A | DBT | 5.0 | N/A | Design, Build & Test (PIT) |  |  |  |  |  |
| 90 | 1.3.3.3.1 | Design | manual | 15d | 2022-12-01 A | 2022-12-21 A |  | 100% |  | 2022-12-01 | 2022-12-21 | 15d | 2022-12-01 | 2022-12-21 |  |  |  | SI DevOps |  | DBT | 5.0 | Rebecca Farooq | Design, Build & Test (PIT) | Complete | COMPLETE |  |  |  |
| 91 | 1.3.3.3.2 | Build & Test |  | 50d | 2023-02-16 A | 2023-04-26 A | 90FS+40d | 100% |  | 2023-02-16 | 2023-04-26 | 50d | 2023-02-16 | 2023-04-26 |  |  |  | SI DevOps |  | DBT | 5.0 | Rebecca Farooq | Design, Build & Test (PIT) | Complete | COMPLETE |  |  |  |
| 92 | 1.3.3.3.3 | UAT |  | 10d | 2023-04-27 A | 2023-05-10 A | 91 | 100% |  | 2023-04-27 | 2023-05-10 | 10d | 2023-04-27 | 2023-05-10 |  |  |  | SI Test |  | DBT | 5.0 | Rebecca Farooq | Design, Build & Test (PIT) | Complete | COMPLETE |  |  |  |
| 93 | 1.3.3.3.4 | Beta test |  | 45d | 2023-03-30 A | 2023-05-31 A | 91FS-20d, 95FF | 100% |  | 2023-03-30 | 2023-05-31 | 45d | 2023-03-30 | 2023-05-31 |  |  |  | PP | SI Test | DBT | 5.0 | Rebecca Farooq | Design, Build & Test (PIT) | Complete | COMPLETE |  |  |  |
| 94 | 1.3.3.3.5 | Prepare for release |  | 24d | 2023-04-27 A | 2023-05-30 A | 92SS | 100% |  | 2023-04-27 | 2023-05-30 | 24d | 2023-04-27 | 2023-05-30 |  |  |  | SI DevOps |  | DBT | 5.0 | Rebecca Farooq | Design, Build & Test (PIT) | Complete | COMPLETE |  |  |  |
| 95 | 1.3.3.3.6 | Data Generator released | milestone | 0d | 2023-05-31 A | 2023-05-31 A | 94FS+1d | 100% |  | 2023-05-31 | 2023-05-31 | 0d | 2023-05-31 | 2023-05-31 |  |  |  | SI DevOps |  | DBT | 5.0 | Rebecca Farooq | Design, Build & Test (PIT) | Complete | COMPLETE | T3-DB-0022 | SITAG | T3 |
| 96 | 1.3.4 | **Design Artefact Releases** |  | 504d? | 2023-02-22 A | 2025-01-27 |  | 97% | 15.16d? | 2023-02-22 | 2024-11-13 | 398d | 2023-02-22 | 2023-09-29 | 32331d |  | -0 | N/A | N/A | DBT | 5.0 | N/A | Design, Build & Test (PIT) |  |  |  | DAG |  |
| 97 | 1.3.4.1 | **Interim release 1** |  | 79d | 2023-02-22 A | 2023-06-12 A |  | 100% |  | 2023-02-22 | 2023-06-12 | 79d | 2023-02-22 | 2023-06-28 |  |  |  | N/A | N/A | DBT | 5.0 | N/A | Design, Build & Test (PIT) |  |  |  |  |  |
| 98 | 1.3.4.1.1 | Prioritise DINs and CR |  | 1d | 2023-02-22 A | 2023-02-22 A |  | 100% |  | 2023-02-22 | 2023-02-22 | 1d | 2023-02-22 | 2023-02-22 |  | must start on 2023-02-22 |  | SI Design |  | DBT | 5.0 | Paul Pettitt | Design, Build & Test (PIT) | Complete | COMPLETE |  |  |  |
| 99 | 1.3.4.1.2 | **Industry input session** |  | 7d | 2023-02-23 A | 2023-03-03 A |  | 100% |  | 2023-02-23 | 2023-03-03 | 7d | 2023-02-23 | 2023-03-03 |  |  |  | N/A | N/A | DBT | 5.0 | N/A | Design, Build & Test (PIT) |  |  |  |  |  |
| 100 | 1.3.4.1.2.1 | Raise a CR covering prioritized assessment cluster |  | 1d | 2023-02-23 A | 2023-02-23 A | 98 | 100% |  | 2023-02-23 | 2023-02-23 | 1d | 2023-02-23 | 2023-02-23 |  |  |  | SI Design |  | DBT | 5.0 | Paul Pettitt | Design, Build & Test (PIT) | Complete | COMPLETE |  |  |  |
| 101 | 1.3.4.1.2.2 | Organize Industry Input session to go through significant items to reach consensus |  | 1d | 2023-02-23 A | 2023-02-23 A | 100SS | 100% |  | 2023-02-23 | 2023-02-23 | 1d | 2023-02-23 | 2023-02-23 |  |  |  | SI Design | PP | DBT | 5.0 | Paul Pettitt,Berlinda Kugara | Design, Build & Test (PIT) | Complete | COMPLETE |  |  |  |
| 102 | 1.3.4.1.2.3 | Conduct Meeting |  | 1d | 2023-03-03 A | 2023-03-03 A | 101FS+5d | 100% |  | 2023-03-03 | 2023-03-03 | 1d | 2023-03-03 | 2023-03-03 |  |  |  | SI Design | PP | DBT | 5.0 | Paul Pettitt,Berlinda Kugara | Design, Build & Test (PIT) | Complete | COMPLETE |  |  |  |
| 103 | 1.3.4.1.3 | Update baselined artefacts |  | 10d | 2023-03-24 A | 2023-04-06 A |  | 100% |  | 2023-03-24 | 2023-04-06 | 10d | 2023-03-24 | 2023-04-06 |  |  |  | SI Design |  | DBT | 5.0 | Paul Pettitt | Design, Build & Test (PIT) | Complete | COMPLETE |  |  |  |

Notes:
- 84: Action: 26/7/23 - forecast changed from 15/12/23 - 3/11/23 - Changed from Interim Release 6 to 5. Updated in milestone register

| ID | WBS | Task | Type | Duration | Start | Finish | Predecessors | Complete | Baseline start | Baseline finish | Baseline duration | Baseline 1 start | Baseline 1 finish | Constraint | Baseline cost | Responsible | Involved | Text9 | Update Version | MHHS Resource Name | MHHS Programme Phase | Sched Status | RAG | Milestone ID | Text29 | Tier | Action |
| --- | --- | --- | --- | --- | --- | --- | --- | --- | --- | --- | --- | --- | --- | --- | --- | --- | --- | --- | --- | --- | --- | --- | --- | --- | --- | --- | --- |
| 104 | 1.3.4.1.4 | **Participant review and impact assess changes** |  | 18d | 2023-04-14 A | 2023-05-09 A |  | 100% | 2023-04-14 | 2023-05-09 | 18d | 2023-04-14 | 2023-05-09 |  |  | N/A | N/A | DBT | 5.0 | N/A | Design, Build & Test (PIT) |  |  |  |  |  |  |
| 105 | 1.3.4.1.4.1 | Issue Redline Version of documents |  | 1d | 2023-04-14 A | 2023-04-14 A | 103FS+5d | 100% | 2023-04-14 | 2023-04-14 | 1d | 2023-04-14 | 2023-04-14 |  |  | SI Design |  | DBT | 5.0 | Paul Pettitt | Design, Build & Test (PIT) | Complete | COMPLETE |  |  |  |  |
| 106 | 1.3.4.1.4.2 | Participants provide review comments to common log |  | 17d | 2023-04-17 A | 2023-05-09 A | 105 | 100% | 2023-04-17 | 2023-05-09 | 17d | 2023-04-17 | 2023-05-09 |  |  | PP |  | DBT | 5.0 | Paul Pettitt | Design, Build & Test (PIT) | Complete | COMPLETE |  |  |  |  |
| 107 | 1.3.4.1.5 | **Assurance review** |  | 19d | 2023-05-10 A | 2023-06-05 A |  | 100% | 2023-05-10 | 2023-06-05 | 19d | 2023-05-10 | 2023-06-05 |  |  | N/A | N/A | DBT | 5.0 | N/A | Design, Build & Test (PIT) |  |  |  |  |  |  |
| 108 | 1.3.4.1.5.1 | SI Design Review and Respond to Comments |  | 5d | 2023-05-10 A | 2023-05-16 A | 106 | 100% | 2023-05-10 | 2023-05-16 | 5d | 2023-05-10 | 2023-05-16 |  |  | SI Design |  | DBT | 5.0 | Paul Pettitt | Design, Build & Test (PIT) | Complete | COMPLETE |  |  |  |  |
| 109 | 1.3.4.1.5.2 | Prep for Assurance Review Meeting |  | 7d | 2023-05-17 A | 2023-05-25 A | 108 | 100% | 2023-05-17 | 2023-05-25 | 7d | 2023-05-17 | 2023-05-25 |  |  | SI Design |  | DBT | 5.0 | Paul Pettitt | Design, Build & Test (PIT) | Complete | COMPLETE |  |  |  |  |
| 110 | 1.3.4.1.5.3 | Conduct Assurance Review Meeting |  | 1d | 2023-05-26 A | 2023-05-26 A | 109 | 100% | 2023-05-26 | 2023-05-26 | 1d | 2023-05-26 | 2023-05-26 |  |  | SI Design |  | DBT | 5.0 | Paul Pettitt | Design, Build & Test (PIT) | Complete | COMPLETE |  |  |  |  |
| 111 | 1.3.4.1.5.4 | Update Artefacts following Assurance Review |  | 6d | 2023-05-29 A | 2023-06-05 A | 110 | 100% | 2023-05-29 | 2023-06-05 | 6d | 2023-05-29 | 2023-06-05 |  |  | SI Design |  | DBT | 5.0 | Paul Pettitt | Design, Build & Test (PIT) | Complete | COMPLETE |  |  |  |  |
| 112 | 1.3.4.1.6 | PSG Approval of interim release plan |  | 1d | 2023-06-08 A | 2023-06-08 A |  | 100% | 2023-06-08 | 2023-06-08 | 1d |  |  | must start on 2023-06-08 |  | PP | SI Design | DBT | 5.1 | Paul Pettitt | Design, Build & Test (PIT) | Complete | COMPLETE |  |  |  |  |
| 113 | 1.3.4.1.7 | Publish updated baselined artefacts | milestone | 0d | 2023-06-06 A | 2023-06-12 A | 111 | 100% | 2023-06-06 | 2023-06-12 | 5d | 2023-06-15 | 2023-06-21 |  |  | SI Design |  | DBT | 5.0 | Paul Pettitt | Design, Build & Test (PIT) | Complete | COMPLETE |  |  |  |  |
| 114 | 1.3.4.1.8 | Interim release 1 Go live | milestone | 0d | 2023-06-12 A | 2023-06-12 A | 113 | 100% | 2023-06-12 | 2023-06-12 | 0d | 2023-06-28 | 2023-06-28 |  |  | SI Design |  | DBT | 5.0 | Paul Pettitt | Design, Build & Test (PIT) | Complete | COMPLETE | T3-DB-0095 | DAG | T3 |  |
| 115 | 1.3.4.2 | **Interim release 2** |  | 27d | 2023-05-30 A | 2023-07-05 A |  | 100% | 2023-05-30 | 2023-07-05 | 27d | 2023-05-24 | 2023-07-28 |  |  | N/A | N/A | DBT | 5.0 | N/A | Design, Build & Test (PIT) |  |  |  |  |  |  |
| 116 | 1.3.4.2.1 | Update baselined artefacts |  | 27d | 2023-05-30 A | 2023-07-05 A |  | 100% | 2023-05-30 | 2023-07-05 | 27d |  |  | must start on 2023-05-30 |  | SI Design | PP | DBT | 5.1 | Paul Pettitt | Design, Build & Test (PIT) | Complete | COMPLETE |  |  |  |  |
| 117 | 1.3.4.2.2 | Interim release 2 Go live | milestone | 0d | 2023-07-05 A | 2023-07-05 A | 116 | 100% | 2023-07-05 | 2023-07-05 | 0d | 2023-07-28 | 2023-07-28 |  |  | SI Design |  | DBT | 5.0 | Paul Pettitt | Design, Build & Test (PIT) | Complete | COMPLETE | T3-DB-0096 | DAG | T3 |  |
| 118 | 1.3.4.3 | **Interim release 3** |  | 35d | 2023-06-15 A | 2023-08-02 A |  | 100% | 2023-06-15 | 2023-08-02 | 35d | 2023-06-29 | 2023-09-29 |  |  | N/A | N/A | DBT | 5.0 | N/A | Design, Build & Test (PIT) |  |  |  |  |  |  |
| 119 | 1.3.4.3.1 | Update baselined artefacts |  | 35d | 2023-06-15 A | 2023-08-02 A |  | 100% | 2023-06-15 | 2023-08-02 | 35d |  |  | must start on 2023-06-15 |  | SI Design | PP | DBT | 5.1 | Paul Pettitt | Design, Build & Test (PIT) | Complete | COMPLETE |  |  |  |  |
| 120 | 1.3.4.3.2 | Interim release 3 Go live | milestone | 0d | 2023-08-02 A | 2023-08-02 A | 119 | 100% | 2023-08-02 | 2023-08-02 | 0d | 2023-09-29 | 2023-09-29 |  |  | SI Design |  | DBT | 5.0 | Paul Pettitt | Design, Build & Test (PIT) | Complete | COMPLETE | T3-DB-0097 | DAG | T3 |  |
| 121 | 1.3.4.4 | **Interim release 4** |  | 36d | 2023-07-12 A | 2023-08-30 A |  | 100% | 2023-07-12 | 2023-08-30 | 36d |  |  |  |  | N/A | N/A | DBT | 5.1 | N/A | Design, Build & Test (PIT) |  |  |  |  |  |  |
| 122 | 1.3.4.4.1 | Update baselined artefacts |  | 36d | 2023-07-12 A | 2023-08-30 A |  | 100% | 2023-07-12 | 2023-08-30 | 36d |  |  | must start on 2023-07-12 |  | SI Design | PP | DBT | 5.1 | Paul Pettitt | Design, Build & Test (PIT) | Complete | COMPLETE |  |  |  |  |
| 123 | 1.3.4.4.2 | Interim release 4 Go live | milestone | 0d | 2023-08-30 A | 2023-08-30 A | 122 | 100% | 2023-08-30 | 2023-08-30 | 0d |  |  |  |  | SI Design |  | DBT | 5.1 | Paul Pettitt | Design, Build & Test (PIT) | Complete | COMPLETE | T3-DB-0081 | DAG | T3 |  |
| 124 | 1.3.4.5 | **Interim release 5** |  | 147d | 2023-08-17 A | 2024-03-08 A |  | 100% | 2023-08-17 | 2024-03-08 | 147d |  |  |  | -0 | N/A | N/A | DBT | 5.1 | N/A | Design, Build & Test (PIT) |  |  |  |  |  |  |
| 125 | 1.3.4.5.1 | Update baselined artefacts |  | 35d | 2023-08-17 A | 2023-10-04 A |  | 100% | 2023-08-17 | 2023-10-04 | 35d |  |  | must start on 2023-08-17 |  | SI Design | PP | DBT | 5.1 | Paul Pettitt | Design, Build & Test (PIT) | Complete | COMPLETE |  |  |  |  |
| 126 | 1.3.4.5.2 | Interim release 5 Go live | milestone | 0d | 2023-10-04 A | 2023-10-04 A | 125 | 100% | 2023-10-04 | 2023-10-04 | 0d |  |  |  |  | SI Design |  | DBT | 5.1 | Paul Pettitt | Design, Build & Test (PIT) | Complete | COMPLETE | T3-DB-0083 | DAG | T3 | 11/8 - successor is SIT functional (starts in march) |
| 127 | 1.3.4.5.3 | Interim Release 5 Deployed to SIT |  | 10d | 2024-02-26 A | 2024-03-08 A | 126FS+102d | 100% | 2024-02-26 | 2024-03-08 | 10d |  |  |  |  | SI Testing | PP | DBT | 5.16 |  |  | Complete | COMPLETE |  |  |  |  |

| ID | WBS | Task | Type | Duration | Start | Finish | Predecessors | Complete | Remaining | Baseline start | Baseline finish | Baseline duration | Total slack | Constraint | Baseline cost | Responsible | Involved | Text9 | Update Version | MHHS Resource Name | MHHS Programme Phase | Sched Status | RAG | Milestone ID | Text29 | Tier | Action | Task Status |
| --- | --- | --- | --- | --- | --- | --- | --- | --- | --- | --- | --- | --- | --- | --- | --- | --- | --- | --- | --- | --- | --- | --- | --- | --- | --- | --- | --- | --- |
| 128 | 1.3.4.6 | **Interim release 6** |  | 192d | 2023-09-14 A | 2024-06-07 A |  | 100% |  | 2023-09-14 | 2024-06-07 | 192d |  |  | -0 | N/A | N/A | DBT | 5.1 | N/A | Design, Build & Test (PIT) |  |  |  |  |  |  |  |
| 129 | 1.3.4.6.1 | Update baselined artefacts |  | 35d | 2023-09-14 A | 2023-11-01 A |  | 100% |  | 2023-09-14 | 2023-11-01 | 32d |  | must start on 2023-09-14 |  | SI Design | PP | DBT | 5.1 | Paul Pettitt | Design, Build & Test (PIT) | Complete | COMPLETE |  |  |  |  |  |
| 130 | 1.3.4.6.2 | Interim release 6 Go live | milestone | 0d | 2023-11-01 A | 2023-11-01 A | 129 | 100% |  | 2023-11-01 | 2023-11-01 | 0d |  |  |  | SI Design |  | DBT | 5.11 | Paul Pettitt | Design, Build & Test (PIT) | Complete | COMPLETE | T3-DB-0085 | DAG | T3 |  |  |
| 131 | 1.3.4.6.3 | Interim Release 6 Deployed to SIT |  | 10d | 2024-05-27 A | 2024-06-07 A | 130FS+147d | 100% |  | 2024-05-27 | 2024-06-07 | 10d |  |  |  | SI Testing | PP | DBT | 5.16 |  |  | Complete | COMPLETE |  |  |  |  |  |
| 132 | 1.3.4.7 | **Interim release 7** |  | 168d | 2023-10-18 A | 2024-06-07 A |  | 100% |  | 2023-10-18 | 2024-06-07 | 168d |  |  | -0 | N/A | N/A | DBT | 5.5 | N/A | Design, Build & Test (PIT) |  |  |  |  |  |  |  |
| 133 | 1.3.4.7.1 | Update baselined artefacts |  | 76d | 2023-10-18 A | 2024-01-31 A |  | 100% |  | 2023-10-18 | 2024-01-31 | 76d |  | start no earlier than 2023-10-18 |  | SI Design | PP | DBT | 5.5 | Paul Pettitt | Design, Build & Test (PIT) | Complete | COMPLETE |  |  |  |  |  |
| 134 | 1.3.4.7.2 | Interim release 7 Go live | milestone | 0d | 2024-01-31 A | 2024-01-31 A | 133 | 100% |  | 2024-01-31 | 2024-01-31 | 0d |  |  |  | SI Design | PP | DBT | 5.14 | Paul Pettitt | Design, Build & Test (PIT) | Complete | COMPLETE | T3-DB-0098 | DAG | T3 | 4/8 - add as t3 milestones. Awaiting approval at TMAG |  |
| 135 | 1.3.4.7.3 | Interim Release 7 Deployed to SIT |  | 10d | 2024-05-27 A | 2024-06-07 A | 134FS+82d | 100% |  | 2024-05-27 | 2024-06-07 | 10d |  |  |  | SI Testing | PP | DBT | 5.16 |  |  | Complete | COMPLETE |  |  |  |  |  |
| 136 | 1.3.4.8 | **Interim release 8** |  | 249d? | 2024-02-14 A | 2025-01-27 |  | 84% | 40.93d? | 2024-02-14 | 2024-11-13 | 143d | 32331d |  | -0 | N/A | N/A | DBT | 5.5 | N/A | Design, Build & Test (PIT) |  |  |  | DAG |  |  |  |
| 137 | 1.3.4.8.1 | Update baselined artefacts |  | 36d | 2024-02-14 A | 2024-04-03 A |  | 100% |  | 2024-02-14 | 2024-04-03 | 36d |  | start no earlier than 2024-02-14 |  | SI Design | PP | DBT | 5.5 | Paul Pettitt | Design, Build & Test (PIT) | Complete | COMPLETE |  |  |  |  |  |
| 138 | 1.3.4.8.2 | Interim release 8 Go live | milestone | 0d | 2024-04-03 A | 2024-04-03 A | 137 | 100% |  | 2024-04-03 | 2024-04-03 | 0d |  | start no earlier than 2024-01-10 |  | SI Design | PP | DBT | 5.14 | Paul Pettitt | Design, Build & Test (PIT) | Complete | COMPLETE | T3-DB-0099 | DAG | T3 | 4/8 - add as t3 milestones. Awaiting approval at TMAG |  |
| 139 | 1.3.4.8.3 | **Interim Release 8.3 - Maintenance Window** |  | 11d | 2024-10-07 A | 2024-10-21 A |  | 100% |  | 2024-10-07 | 2024-10-21 | 0d |  |  |  | Design |  | DBT | 6.0 |  |  | Overdue Start |  |  |  |  |  | -686.67 |
| 140 | 1.3.4.8.3.1 | Interim Release 8.3 'effective from date' to SIT A | milestone | 0d | 2024-10-21 A | 2024-10-21 A | 138FS+143d | 100% |  | 2024-10-21 | 2024-10-21 | 10d |  |  |  | SI Testing | PP | DBT | 5.16 | Roger Robar |  | Complete | COMPLETE |  |  |  |  |  |
| 141 | 1.3.4.8.3.2 | Interim Release 8.3 'effective from date' to SIT B | milestone | 0d | 2024-10-07 A | 2024-10-07 A | 140SS-11d | 100% |  | 2024-10-07 | 2024-10-07 | 0d |  |  |  | Design |  | DBT | 5.16 |  |  | Complete | COMPLETE |  |  |  |  |  |
| 142 | 1.3.4.8.4 | **Interim Release 8.4** |  | 49d | 2024-09-25 A | 2024-12-02 A |  | 100% |  | 2024-09-25 | 2024-11-13 | 0d |  |  |  | Design |  | DBT | 6.1 | Paul Pettitt |  | Overdue Start |  |  | DAG |  |  | -694.67 |
| 143 | 1.3.4.8.4.1 | Update baselined artefacts |  | 8d | 2024-09-25 A | 2024-10-04 A |  | 100% |  | 2024-09-25 | 2024-10-04 | 0d |  | start no earlier than 2024-09-25 |  | Design |  | DBT | 6.1 | Paul Pettitt |  | Complete | COMPLETE |  |  |  |  |  |
| 144 | 1.3.4.8.4.2 | Interim Release 8.4 Published | milestone | 0d | 2024-10-16 A | 2024-10-16 A | 143FS+8d | 100% |  | 2024-10-16 | 2024-10-16 | 0d |  | start no earlier than 2024-10-09 |  | Design |  | DBT | 6.1 | Paul Pettitt |  | Complete | COMPLETE | T3-DB-0184 | DAG | T3 |  |  |
| 145 | 1.3.4.8.4.3 | Interim Release 8.4 Deployed to SIT by Participants |  | 6d | 2024-11-25 A | 2024-12-02 A | 144FS+25d | 100% |  | 2024-11-13 | 2024-11-13 | 0d |  |  |  | Design |  | DBT | 6.12 | Paul Pettitt |  | Complete | COMPLETE |  |  |  |  |  |
| 146 | 1.3.4.8.5 | **Interim Release 8.5** |  | 71d | 2024-10-16 A | 2025-01-22 |  | 73% | 19.36d | 2024-10-16 | 2024-12-04 | 0d | 32334d |  |  | Design |  | DBT | 6.11 | Paul Pettitt |  | Overdue Start |  |  | DAG |  |  | -728.67 |
| 147 | 1.3.4.8.5.1 | Update baselined artefacts |  | 8d | 2024-10-16 A | 2024-10-25 A |  | 100% |  | 2024-10-16 | 2024-10-25 | 0d |  | start no earlier than 2024-10-16 |  | Design |  | DBT | 6.11 | Paul Pettitt |  | Complete | COMPLETE |  |  |  |  |  |
| 148 | 1.3.4.8.5.2 | Interim Release 8.5 Published | milestone | 0d | 2024-11-06 A | 2024-11-06 A | 147FS+8d | 100% |  | 2024-11-06 | 2024-11-06 | 0d |  |  |  | Design |  | DBT | 6.11 | Paul Pettitt |  | Complete | COMPLETE | T3-DB-0185 | DAG | T3 |  |  |
| 149 | 1.3.4.8.5.3 | Interim Release 8.5 Deployed to SIT by Participants |  | 3d | 2025-01-20 | 2025-01-22 | 148FS+52d |  |  | 2024-12-04 | 2024-12-04 | 0d | 32334d |  |  | Design |  | DBT | 6.12 | Paul Pettitt |  | Red | RED |  |  |  |  | 31.33 |
| 150 | 1.3.4.8.6 | **Interim Release 8.6** |  | 45d? | 2024-11-21 A | 2025-01-22 |  | 50% | 22.5d? | 2024-11-21 | 2025-01-22 | 0d | 32334d |  |  | Design |  | DBT | 6.14 | Paul Pettitt |  | Overdue Start |  |  | DAG |  |  | -769.67 |
| 151 | 1.3.4.8.6.1 | Update baselined artefacts |  | 2d? | 2024-11-21 A | 2024-11-22 A |  | 100% |  | 2024-11-21 | 2024-11-22 | 0d |  | start no earlier than 2024-11-21 |  |  |  | DBT | 6.14 | Paul Pettitt |  | Complete | COMPLETE |  |  |  |  |  |
| 152 | 1.3.4.8.6.2 | Interim Release 8.6 Published |  | 1d? | 2024-11-25 A | 2024-11-25 A | 151 | 100% |  | 2024-11-25 | 2024-11-25 | 0d |  |  |  |  |  | DBT | 6.14 | Paul Pettitt |  | Complete | COMPLETE |  |  |  |  |  |
| 153 | 1.3.4.8.6.3 | Interim Release 8.6 Deployed to SIT by Participants |  | 3d | 2025-01-20 | 2025-01-22 | 152FS+39d |  |  | 2025-01-20 | 2025-01-22 | 0d | 32334d |  |  | Design |  | DBT | 6.14 | Paul Pettitt |  | Green | GREEN | T3-TE-0187 | DAG | T3 |  | 31.33 |

| ID | WBS | Task | Duration | Start | Finish | Predecessors | Complete | Remaining | Baseline start | Baseline finish | Baseline duration | Baseline 1 start | Baseline 1 finish | Total slack | Free slack | Constraint | Baseline cost | Responsible | Text9 | Task Status | Update Version | Sched Status | MHHS Resource Name | Text29 | RAG | Milestone ID | Tier | Involved | MHHS Programme Phase | Action |
| --- | --- | --- | --- | --- | --- | --- | --- | --- | --- | --- | --- | --- | --- | --- | --- | --- | --- | --- | --- | --- | --- | --- | --- | --- | --- | --- | --- | --- | --- | --- |
| 154 | 1.3.4.8.7 | **Interim Release 8.7 Placeholder** | 6d | 2025-01-20 | 2025-01-27 |  |  |  | 2025-01-20 | 2025-01-27 |  |  |  | 32331d |  |  |  | Design | DBT | -769.67 | 6.15 | Overdue Start | Paul Pettitt | DAG |  |  |  |  |  |  |
| 155 | 1.3.4.8.7.1 | Update baselined artefacts | 2d | 2025-01-20 | 2025-01-21 |  |  |  | 2025-01-20 | 2025-01-21 |  |  |  | 32331d | 0d | start no earlier than 2025-01-20 |  |  | DBT | 31.33 | 6.15 | Green | Paul Pettitt |  | GREEN |  |  |  |  |  |
| 156 | 1.3.4.8.7.2 | Interim Release 8.7 Published | 1d | 2025-01-22 | 2025-01-22 | 155 |  |  | 2025-01-22 | 2025-01-22 |  |  |  | 32331d | 0d |  |  |  | DBT | 33.33 | 6.15 | Green | Paul Pettitt |  | GREEN |  |  |  |  |  |
| 157 | 1.3.4.8.7.3 | Interim Release 8.7 Deployed to SIT by Participants | 3d | 2025-01-23 | 2025-01-27 | 156 |  |  | 2025-01-23 | 2025-01-27 |  |  |  | 32331d |  |  |  | Design | DBT | 34.33 | 6.15 | Green | Paul Pettitt | DAG | GREEN | T3-TE-0188 | T3 |  |  |  |
| 158 | 1.3.5 | **Queries Support / Knowledgebase & Tool Roll-Out (Systems)** | 325d | 2023-01-03 A | 2024-04-01 A |  | 100% |  | 2023-01-03 | 2024-04-01 | 325d | 2023-01-03 | 2024-04-01 |  |  |  |  | N/A | DBT |  | 5.0 |  | N/A |  |  |  |  | N/A | Design, Build & Test (PIT) |  |
| 159 | 1.3.5.1 | **Query Management** | 325d | 2023-01-03 A | 2024-04-01 A |  | 100% |  | 2023-01-03 | 2024-04-01 | 325d | 2023-01-03 | 2024-04-01 |  |  |  |  | N/A | DBT |  | 5.0 |  | N/A |  |  |  |  | N/A | Design, Build & Test (PIT) |  |
| 160 | 1.3.5.1.1 | Respond to Participant Queries | 325d | 2023-01-03 A | 2024-04-01 A |  | 100% |  | 2023-01-03 | 2024-04-01 | 325d | 2023-01-03 | 2024-04-01 |  |  | must start on 2023-01-03 |  | SI Design | DBT |  | 5.0 | Complete | Paul Pettitt |  | COMPLETE |  |  | PP | Design, Build & Test (PIT) | 11/8 - runs out to end of the programme |
| 161 | 1.3.5.1.2 | Respond to Programme Queries | 325d | 2023-01-03 A | 2024-04-01 A | 160SS | 100% |  | 2023-01-03 | 2024-04-01 | 325d | 2023-01-03 | 2024-04-01 |  |  |  |  | SI Design | DBT |  | 5.0 | Complete | Paul Pettitt |  | COMPLETE |  |  | PP | Design, Build & Test (PIT) | 11/8 - runs out to end of the programme |
| 162 | 1.3.5.2 | **Query Support tooling (FreshDesk)** | 23d | 2023-06-01 A | 2023-07-03 A |  | 100% |  | 2023-06-01 | 2023-07-03 | 23d | 2023-06-01 | 2023-07-03 |  |  |  |  | N/A | DBT |  | 5.0 |  | N/A |  |  |  |  | N/A | Design, Build & Test (PIT) |  |
| 163 | 1.3.5.2.1 | Migrate to Standalone Freshdesk | 10d | 2023-06-01 A | 2023-06-14 A |  | 100% |  | 2023-06-01 | 2023-06-14 | 10d | 2023-06-01 | 2023-06-14 |  |  | must start on 2023-06-01 |  | SI Design | DBT |  | 5.0 | Complete | Paul Pettitt |  | COMPLETE |  |  |  | Design, Build & Test (PIT) |  |
| 164 | 1.3.5.2.2 | Develop reporting dashboard | 5d | 2023-06-15 A | 2023-06-21 A | 163 | 100% |  | 2023-06-15 | 2023-06-21 | 5d | 2023-06-15 | 2023-06-21 |  |  |  |  | SI Design | DBT |  | 5.0 | Complete | Paul Pettitt |  | COMPLETE |  |  |  | Design, Build & Test (PIT) |  |
| 165 | 1.3.5.2.3 | Issue to SRO for Review | 5d | 2023-06-22 A | 2023-06-28 A | 164 | 100% |  | 2023-06-22 | 2023-06-28 | 5d | 2023-06-22 | 2023-06-28 |  |  |  |  | SI Design | DBT |  | 5.0 | Complete | Paul Pettitt |  | COMPLETE |  |  |  | Design, Build & Test (PIT) |  |
| 166 | 1.3.5.2.4 | Update following review | 2d | 2023-06-29 A | 2023-06-30 A | 165 | 100% |  | 2023-06-29 | 2023-06-30 | 2d | 2023-06-29 | 2023-06-30 |  |  |  |  | SI Design | DBT |  | 5.0 | Complete | Paul Pettitt |  | COMPLETE |  |  |  | Design, Build & Test (PIT) |  |
| 167 | 1.3.5.2.5 | Sign off | 1d | 2023-07-03 A | 2023-07-03 A | 166 | 100% |  | 2023-07-03 | 2023-07-03 | 1d | 2023-07-03 | 2023-07-03 |  |  |  |  | SI Design | DBT |  | 5.0 | Complete | Paul Pettitt |  | COMPLETE |  |  |  | Design, Build & Test (PIT) |  |
| 168 | 1.3.5.3 | **KnowledgeBase Development** | 72d | 2023-06-01 A | 2023-09-08 A |  | 100% |  | 2023-06-01 | 2023-09-08 | 72d | 2023-06-01 | 2023-09-08 |  |  |  |  | N/A | DBT |  | 5.0 |  | N/A |  |  |  |  | N/A | Design, Build & Test (PIT) |  |
| 169 | 1.3.5.3.1 | Define Scope of KB | 1d | 2023-06-01 A | 2023-06-01 A | 163SS | 100% |  | 2023-06-01 | 2023-06-01 | 1d | 2023-06-01 | 2023-06-01 |  |  |  |  | SI Design | DBT |  | 5.0 | Complete | Paul Pettitt |  | COMPLETE |  |  |  | Design, Build & Test (PIT) |  |
| 170 | 1.3.5.3.2 | Capture Existing KB artefacts | 20d | 2023-06-02 A | 2023-06-29 A | 169 | 100% |  | 2023-06-02 | 2023-06-29 | 20d | 2023-06-02 | 2023-06-29 |  |  |  |  | SI Design | DBT |  | 5.0 | Complete | Paul Pettitt |  | COMPLETE |  |  |  | Design, Build & Test (PIT) |  |
| 171 | 1.3.5.3.3 | Tag artefacts | 5d | 2023-06-30 A | 2023-07-06 A | 170 | 100% |  | 2023-06-30 | 2023-07-06 | 5d | 2023-06-30 | 2023-07-06 |  |  |  |  | SI Design | DBT |  | 5.0 | Complete | Paul Pettitt |  | COMPLETE |  |  |  | Design, Build & Test (PIT) |  |
| 172 | 1.3.5.3.4 | Develop Participant Interfaces | 20d | 2023-07-07 A | 2023-08-03 A | 171 | 100% |  | 2023-07-07 | 2023-08-03 | 20d | 2023-07-07 | 2023-08-03 |  |  |  |  | SI Design | DBT |  | 5.0 | Complete | Paul Pettitt |  | COMPLETE |  |  |  | Design, Build & Test (PIT) |  |
| 173 | 1.3.5.3.5 | Promote to Collaboration Portal | 21d | 2023-08-04 A | 2023-09-01 A | 172 | 100% |  | 2023-08-04 | 2023-09-01 | 21d | 2023-08-04 | 2023-09-01 |  |  |  |  | SI Design | DBT |  | 5.0 | Complete | Paul Pettitt |  | COMPLETE |  |  |  | Design, Build & Test (PIT) |  |
| 174 | 1.3.5.3.6 | Link into FreshDesk | 5d | 2023-09-04 A | 2023-09-08 A | 173 | 100% |  | 2023-09-04 | 2023-09-08 | 5d | 2023-09-04 | 2023-09-08 |  |  |  |  | SI Design | DBT |  | 5.0 | Complete | Paul Pettitt |  | COMPLETE |  |  |  | Design, Build & Test (PIT) |  |
| 175 | 1.3.6 | **PP Design, Build & Test (DBT)** | 1221d? | 2022-10-31 A | 2027-07-05 |  | 83% | 209.95d? | 2022-10-31 | 2027-07-05 | 495d | 2022-10-31 | 2026-02-16 | 31696d |  |  | -0 | N/A | DBT |  | 5.0 |  | N/A |  |  |  |  | N/A | Design, Build & Test (PIT) |  |
| 176 | 1.3.6.1 | **PP Impact Assessment, Planning & Procurement** | 110d | 2022-10-31 A | 2023-03-31 A |  | 100% |  | 2022-10-31 | 2023-03-31 | 110d | 2022-10-31 | 2023-03-31 |  |  |  |  | N/A | DBT |  | 5.0 |  | N/A |  |  |  |  | N/A | Design, Build & Test (PIT) |  |
| 177 | 1.3.6.1.1 | **PP Impact Assessment** | 67d | 2022-10-31 A | 2023-01-31 A |  | 100% |  | 2022-10-31 | 2023-01-31 | 67d | 2022-10-31 | 2023-01-31 |  |  |  |  | N/A | DBT |  | 5.0 |  | N/A |  |  |  |  | N/A | Design, Build & Test (PIT) |  |
| 178 | 1.3.6.1.1.1 | Develop heatmap for impact of MHHS | 67d | 2022-10-31 A | 2023-01-31 A | 47 | 100% |  | 2022-10-31 | 2023-01-31 | 67d | 2022-10-31 | 2023-01-31 |  |  |  |  | PP | DBT |  | 5.0 | Complete | PP |  | COMPLETE |  |  |  | Design, Build & Test (PIT) |  |
| 179 | 1.3.6.1.1.2 | Develop detailed impact assessment | 67d | 2022-10-31 A | 2023-01-31 A | 47 | 100% |  | 2022-10-31 | 2023-01-31 | 67d | 2022-10-31 | 2023-01-31 |  |  |  |  | PP | DBT |  | 5.0 | Complete | PP |  | COMPLETE |  |  |  | Design, Build & Test (PIT) |  |

Notes:
- 155: 18/12/24 - These are placeholder dates which the programme will update in due course.
- 156: 18/12/24 - These are placeholder dates which the programme will update in due course.
- 157: 18/12/24 - These are placeholder dates which the programme will update in due course.

| ID | WBS | Task | Duration | Start | Finish | Predecessors | Complete | Remaining | Baseline start | Baseline finish | Baseline duration | Baseline 1 start | Baseline 1 finish | Total slack | Free slack | Constraint | Responsible | Involved | Text9 | Update Version | MHHS Resource Name | MHHS Programme Phase | Sched Status | RAG | Task Status |
| --- | --- | --- | --- | --- | --- | --- | --- | --- | --- | --- | --- | --- | --- | --- | --- | --- | --- | --- | --- | --- | --- | --- | --- | --- | --- |
| 180 | 1.3.6.1.2 | **PP Planning** | 67d | 2022-10-31 A | 2023-01-31 A |  | 100% |  | 2022-10-31 | 2023-01-31 | 67d | 2022-10-31 | 2023-01-31 |  |  |  | N/A | N/A | DBT | 5.0 | N/A | Design, Build & Test (PIT) |  |  |  |
| 181 | 1.3.6.1.2.1 | Develop detailed short-term plan | 23d | 2022-10-31 A | 2022-11-30 A | 47 | 100% |  | 2022-10-31 | 2022-11-30 | 23d | 2022-10-31 | 2022-11-30 |  |  |  | PP |  | DBT | 5.0 | PP | Design, Build & Test (PIT) | Complete | COMPLETE |  |
| 182 | 1.3.6.1.2.2 | Develop overall project plan for implementation | 67d | 2022-10-31 A | 2023-01-31 A | 47 | 100% |  | 2022-10-31 | 2023-01-31 | 67d | 2022-10-31 | 2023-01-31 |  |  |  | PP |  | DBT | 5.0 | PP | Design, Build & Test (PIT) | Complete | COMPLETE |  |
| 183 | 1.3.6.1.2.3 | Develop procurement plan | 67d | 2022-10-31 A | 2023-01-31 A | 47 | 100% |  | 2022-10-31 | 2023-01-31 | 67d | 2022-10-31 | 2023-01-31 |  |  |  | PP |  | DBT | 5.0 | PP | Design, Build & Test (PIT) | Complete | COMPLETE |  |
| 184 | 1.3.6.1.3 | **PP Software/Service Procurement** | 110d | 2022-10-31 A | 2023-03-31 A |  | 100% |  | 2022-10-31 | 2023-03-31 | 110d | 2022-10-31 | 2023-03-31 |  |  |  | N/A | N/A | DBT | 5.0 | N/A | Design, Build & Test (PIT) |  |  |  |
| 185 | 1.3.6.1.3.1 | Run tender process | 67d | 2022-10-31 A | 2023-01-31 A | 47 | 100% |  | 2022-10-31 | 2023-01-31 | 67d | 2022-10-31 | 2023-01-31 |  |  |  | PP |  | DBT | 5.0 | PP | Design, Build & Test (PIT) | Complete | COMPLETE |  |
| 186 | 1.3.6.1.3.2 | Select provider & sign commercials | 43d | 2023-02-01 A | 2023-03-31 A | 185 | 100% |  | 2023-02-01 | 2023-03-31 | 43d | 2023-02-01 | 2023-03-31 |  |  |  | PP |  | DBT | 5.0 | PP | Design, Build & Test (PIT) | Complete | COMPLETE |  |
| 187 | 1.3.6.2 | **Design Handover** | 741d? | 2024-09-02 A | 2027-07-05 |  | 6% | 696.65d? | 2024-09-02 | 2027-07-05 | 0d |  |  | 31696d |  |  | Design |  | DBT | 6.1 | Paul Pettitt |  | Overdue Start |  | -694.67 |
| 188 | 1.3.6.2.1 | **Creation of the Configuration Management Database** | 14d | 2024-09-02 A | 2024-09-19 A |  | 100% |  | 2024-09-02 | 2024-09-19 | 0d |  |  |  |  |  | Design |  | DBT | 6.1 | Paul Pettitt |  | Overdue Start |  | -701.67 |
| 189 | 1.3.6.2.1.1 | Identify all baselined design artefacts | 9d | 2024-09-02 A | 2024-09-12 A |  | 100% |  | 2024-09-02 | 2024-09-12 | 0d |  |  |  |  | start no earlier than 2024-09-02 | Design |  | DBT | 6.1 | Paul Pettitt |  | Complete | COMPLETE |  |
| 190 | 1.3.6.2.1.2 | Create CMBD | 5d | 2024-09-13 A | 2024-09-19 A | 189 | 100% |  | 2024-09-13 | 2024-09-19 | 0d |  |  |  |  |  | Design |  | DBT | 6.1 | Paul Pettitt |  | Complete | COMPLETE |  |
| 191 | 1.3.6.2.2 | **Knowledge Transfer** | 41d? | 2024-09-02 | 2024-10-28 |  |  |  | 2024-09-02 | 2024-10-28 | 0d |  |  | 32396d |  |  | Design |  | DBT | 6.1 | Paul Pettitt |  | Overdue Start | RED | -701.67 |
| 192 | 1.3.6.2.2.1 | Elexon to document knowledge transfer requirements | 9d? | 2024-09-02 | 2024-09-12 |  |  |  | 2024-09-02 | 2024-09-12 | 0d |  |  | 32407d | 0d | start no earlier than 2024-09-02 | Design |  | DBT | 6.1 | Paul Pettitt |  | Overdue Start | RED | -108.67 |
| 193 | 1.3.6.2.2.2 | Review Requirements | 5d | 2024-09-13 | 2024-09-19 | 192 |  |  | 2024-09-13 | 2024-09-19 | 0d |  |  | 32407d | 0d |  | Design |  | DBT | 6.1 | Paul Pettitt |  | Overdue Start | RED | -97.67 |
| 194 | 1.3.6.2.2.3 | Agree Success Criteria | 10d | 2024-09-20 | 2024-10-03 | 193 |  |  | 2024-09-20 | 2024-10-03 | 0d |  |  | 32407d | 0d |  | Design |  | DBT | 6.1 | Paul Pettitt |  | Overdue Start | RED | -90.67 |
| 195 | 1.3.6.2.2.4 | Identify Key personel with Elexon | 3d | 2024-10-04 | 2024-10-08 | 194 |  |  | 2024-10-04 | 2024-10-08 | 0d |  |  | 32407d | 0d |  | Design |  | DBT | 6.1 | Paul Pettitt |  | Overdue Start | RED | -76.67 |
| 196 | 1.3.6.2.2.5 | Draft Agenda for initial meeting | 1d? | 2024-10-09 | 2024-10-09 | 195 |  |  | 2024-10-09 | 2024-10-09 | 0d |  |  | 32407d | 0d |  | Design |  | DBT | 6.1 | Paul Pettitt |  | Overdue Start | RED | -71.67 |
| 197 | 1.3.6.2.2.6 | Define cadence for handover sessions | 2d | 2024-10-10 | 2024-10-11 | 196 |  |  | 2024-10-10 | 2024-10-11 | 0d |  |  | 32407d |  |  | Design |  | DBT | 6.1 | Paul Pettitt |  | Overdue Start | RED | -70.67 |
| 198 | 1.3.6.2.2.7 | Share Design Information | 20d | 2024-09-02 | 2024-09-27 |  |  |  | 2024-09-02 | 2024-09-27 | 0d |  |  | 32417d |  | start no earlier than 2024-09-02 | Design |  | DBT | 6.1 | Paul Pettitt |  | Overdue Start | RED | -108.67 |
| 199 | 1.3.6.2.2.8 | Conduct Initial Handover Session | 20d? | 2024-10-01 | 2024-10-28 |  |  |  | 2024-10-01 | 2024-10-28 | 0d |  |  | 32396d |  | start no earlier than 2024-10-01 | Design |  | DBT | 6.1 | Paul Pettitt |  | Overdue Start | RED | -79.67 |
| 200 | 1.3.6.2.3 | **Triage Sessions** | 131d? | 2024-10-01 | 2025-04-01 |  |  |  | 2024-10-01 | 2025-04-01 | 0d |  |  | 32285d |  |  | Design |  | DBT | 6.1 | Paul Pettitt |  | Overdue Start | RED | -701.67 |
| 201 | 1.3.6.2.3.1 | Design Triage Sessions | 131d? | 2024-10-01 | 2025-04-01 |  |  |  | 2024-10-01 | 2025-04-01 | 0d |  |  | 32285d |  | start no earlier than 2024-10-01 | Design |  | DBT | 6.1 | Paul Pettitt |  | Overdue Start | GREEN | -79.67 |
| 202 | 1.3.6.2.3.2 | Test Triage Sessions | 131d? | 2024-10-01 | 2025-04-01 |  |  |  | 2024-10-01 | 2025-04-01 | 0d |  |  | 32285d |  | finish no earlier than 2025-04-01 | Design |  | DBT | 6.1 | Paul Pettitt |  | Overdue Start | GREEN | -79.67 |
| 203 | 1.3.6.2.4 | **Knowledge Base** | 9d | 2024-09-02 A | 2024-09-12 A |  | 100% |  | 2024-09-02 | 2024-09-12 | 0d |  |  |  |  |  | Design |  | DBT | 6.1 | Paul Pettitt |  | Overdue Start | COMPLETE | -701.67 |
| 204 | 1.3.6.2.4.1 | Document Knowledge base update process | 4d | 2024-09-02 A | 2024-09-05 A |  | 100% |  | 2024-09-02 | 2024-09-05 | 0d |  |  |  |  | start no earlier than 2024-09-02 | Design |  | DBT | 6.1 | Paul Pettitt |  | Complete | COMPLETE |  |
| 205 | 1.3.6.2.4.2 | Document Design updates to Collaboration Base | 5d | 2024-09-06 A | 2024-09-12 A |  | 100% |  | 2024-09-06 | 2024-09-12 | 0d |  |  |  |  | start no earlier than 2024-09-06 | Design |  | DBT | 6.1 | Paul Pettitt |  | Complete | COMPLETE |  |

Notes:
- 192: 18/12/24 - Design Handover activities dependent on Helix completing an action before they can be progressed.
- 193: 18/12/24 - Design Handover activities dependent on Helix completing an action before they can be progressed.
- 194: 18/12/24 - Design Handover activities dependent on Helix completing an action before they can be progressed.
- 195: 18/12/24 - Design Handover activities dependent on Helix completing an action before they can be progressed.
- 196: 18/12/24 - Design Handover activities dependent on Helix completing an action before they can be progressed.
- 197: 18/12/24 - Design Handover activities dependent on Helix completing an action before they can be progressed.
- 198: 18/12/24 - Design Handover activities dependent on Helix completing an action before they can be progressed.
- 199: 18/12/24 - Design Handover activities dependent on Helix completing an action before they can be progressed.

| ID | WBS | Task | Type | Duration | Start | Finish | Predecessors | Complete | Remaining | Baseline start | Baseline finish | Baseline duration | Baseline 1 start | Baseline 1 finish | Total slack | Free slack | Constraint | Baseline cost | Responsible | Text9 | Task Status | Update Version | Sched Status | MHHS Resource Name | RAG | Involved | MHHS Programme Phase | Milestone ID | Text29 | Tier |
| --- | --- | --- | --- | --- | --- | --- | --- | --- | --- | --- | --- | --- | --- | --- | --- | --- | --- | --- | --- | --- | --- | --- | --- | --- | --- | --- | --- | --- | --- | --- |
| 206 | 1.3.6.2.5 | **FreshDesk** |  | 30d? | 2025-02-03 | 2025-03-14 |  |  |  | 2025-02-03 | 2025-03-14 | 0d |  |  | 32297d |  |  |  | Design | DBT | -701.67 | 6.1 | Overdue Start | Paul Pettitt | GREEN |  |  |  |  |  |
| 207 | 1.3.6.2.5.1 | Agree Indicative Handover of FreshDesk Calls to Service Now |  | 4d | 2025-02-03 | 2025-02-06 |  |  |  | 2025-02-03 | 2025-02-06 | 0d |  |  | 32323d |  | start no earlier than 2025-02-03 |  | Design | DBT | 45.33 | 6.1 | Green | Paul Pettitt | GREEN |  |  |  |  |  |
| 208 | 1.3.6.2.5.2 | Prepare Comms to Industry |  | 10d | 2025-02-07 | 2025-02-20 |  |  |  | 2025-02-07 | 2025-02-20 | 0d |  |  | 32313d |  | start no earlier than 2025-02-07 |  | Design | DBT | 49.33 | 6.1 | Green | Paul Pettitt | GREEN |  |  |  |  |  |
| 209 | 1.3.6.2.5.3 | Issue Comms to Industry |  | 1d? | 2025-02-21 | 2025-02-21 |  |  |  | 2025-02-21 | 2025-02-21 | 0d |  |  | 32312d |  | start no earlier than 2025-02-21 |  | Design | DBT | 63.33 | 6.1 | Green | Paul Pettitt | GREEN |  |  |  |  |  |
| 210 | 1.3.6.2.5.4 | Redirect Design Mailbox to Service Now |  | 1d? | 2025-03-03 | 2025-03-03 |  |  |  | 2025-03-03 | 2025-03-03 | 0d |  |  | 32306d |  | start no earlier than 2025-03-03 |  | Design | DBT | 73.33 | 6.1 | Green | Paul Pettitt | GREEN |  |  |  |  |  |
| 211 | 1.3.6.2.5.5 | Archive Freshdesk calls |  | 5d | 2025-03-03 | 2025-03-07 |  |  |  | 2025-03-03 | 2025-03-07 | 0d |  |  | 32302d |  | start no earlier than 2025-03-03 |  | Design | DBT | 73.33 | 6.1 | Green | Paul Pettitt | GREEN |  |  |  |  |  |
| 212 | 1.3.6.2.5.6 | Decommission FreshDesk |  | 5d | 2025-03-10 | 2025-03-14 |  |  |  | 2025-03-10 | 2025-03-14 | 0d |  |  | 32297d |  | start no earlier than 2025-03-10 |  | Design | DBT | 80.33 | 6.1 | Green | Paul Pettitt | GREEN |  |  |  |  |  |
| 213 | 1.3.6.2.6 | **iServer** |  | 611d? | 2025-03-03 A | 2027-07-05 |  | 5% | 580.45d? | 2025-03-03 | 2027-07-05 | 0d |  |  |  |  |  |  | Design | DBT | -701.67 | 6.1 | Overdue Start | Paul Pettitt | GREEN |  |  |  |  |  |
| 214 | 1.3.6.2.6.1 | Gather Licensing information |  | 1d? | 2025-03-03 A | 2025-03-03 A |  | 100% |  | 2025-03-03 | 2025-03-03 | 0d |  |  |  |  | start no earlier than 2025-03-03 |  | Design | DBT |  | 6.1 | Complete | Paul Pettitt | COMPLETE |  |  |  |  |  |
| 215 | 1.3.6.2.6.2 | Clear down old information |  | 5d | 2025-03-03 | 2025-03-07 |  |  |  | 2025-03-03 | 2025-03-07 | 0d |  |  | 32288d | 0d |  |  | Design | DBT | 73.33 | 6.1 | Green | Paul Pettitt | GREEN |  |  |  |  |  |
| 216 | 1.3.6.2.6.3 | Clear down accounts |  | 2d | 2025-03-10 | 2025-03-11 | 215 |  |  | 2025-03-10 | 2025-03-11 | 0d |  |  | 32288d | 14d | start no earlier than 2025-03-10 |  | Design | DBT | 80.33 | 6.1 | Green | Paul Pettitt | GREEN |  |  |  |  |  |
| 217 | 1.3.6.2.6.4 | Identify Collaboration Base Design Dependencies on iServer |  | 2d | 2025-04-01 | 2025-04-02 | 216 |  |  | 2025-04-01 | 2025-04-02 | 0d |  |  | 32274d | 0d | start no earlier than 2025-04-01 |  | Design | DBT | 102.33 | 6.1 | Green | Paul Pettitt | GREEN |  |  |  |  |  |
| 218 | 1.3.6.2.6.5 | Remove Design dependencies |  | 5d | 2025-04-03 | 2025-04-09 | 217 |  |  | 2025-04-03 | 2025-04-09 | 0d |  |  | 32274d | 0d | start no earlier than 2025-04-03 |  | Design | DBT | 104.33 | 6.1 | Green | Paul Pettitt | GREEN |  |  |  |  |  |
| 219 | 1.3.6.2.6.6 | Close down iServer |  | 5d | 2025-04-10 | 2025-04-16 | 218 |  |  | 2025-04-10 | 2025-04-16 | 0d |  |  | 32274d |  | start no earlier than 2025-04-10 |  | Design | DBT | 111.33 | 6.1 | Green | Paul Pettitt | GREEN |  |  |  |  |  |
| 220 | 1.3.6.3 | **Central Systems DBT** |  | 325d | 2022-10-31 A | 2024-01-26 A |  | 100% |  | 2022-10-31 | 2024-01-26 | 345d | 2022-10-31 | 2024-05-13 |  |  |  | -0 | N/A | DBT | -316.67 | 5.0 |  | N/A |  | N/A | Design, Build & Test (PIT) |  |  |  |
| 221 | 1.3.6.3.1 | **Elexon Central Systems DBT CIT (Entering at Interval 1)** |  | 248d | 2022-10-31 A | 2023-10-11 A |  | 100% |  | 2022-10-31 | 2023-10-11 | 249d | 2022-10-31 | 2023-09-29 |  |  |  | -0 | N/A | DBT |  | 5.0 |  | N/A |  | N/A | Design, Build & Test (PIT) |  |  |  |
| 222 | 1.3.6.3.1.1 | **Design and Build** |  | 235d | 2022-10-31 A | 2023-09-22 A |  | 100% |  | 2022-10-31 | 2023-09-22 | 240d | 2022-10-31 | 2023-09-29 |  |  |  |  | N/A | DBT | -259.67 | 5.0 |  | N/A |  | N/A | Design, Build & Test (PIT) |  |  |  |
| 223 | 1.3.6.3.1.1.1 | Helix Design and Build |  | 235d | 2022-10-31 A | 2023-09-22 A | 2 | 100% |  | 2022-10-31 | 2023-09-22 | 240d | 2022-10-31 | 2023-09-29 |  |  |  |  | PP | DBT |  | 5.0 | Complete |  | COMPLETE | SI Test | Design, Build & Test (PIT) |  |  |  |
| 224 | 1.3.6.3.1.2 | **Test Approach & Plan** |  | 235d | 2022-10-31 A | 2023-09-22 A |  | 100% |  | 2022-10-31 | 2023-09-22 | 235d | 2022-10-31 | 2023-07-21 |  |  |  | -0 | N/A | DBT |  | 5.0 |  | N/A |  | N/A | Design, Build & Test (PIT) |  |  |  |
| 225 | 1.3.6.3.1.2.1 | Develop Test Approach & Plan |  | 180d | 2022-10-31 A | 2023-07-07 A |  | 100% |  | 2022-10-31 | 2023-07-07 | 180d | 2022-10-31 | 2023-07-07 |  |  |  |  | PP | DBT |  | 5.0 | Complete |  | COMPLETE | SI Test | Design, Build & Test (PIT) |  |  |  |
| 226 | 1.3.6.3.1.2.2 | Elexon Central Systems Test Approach & Plan (PIT) submitted to Programme for assurance | milestone | 0d | 2023-07-13 A | 2023-07-13 A | 225FF+4d | 100% |  | 2023-07-13 | 2023-07-13 | 0d | 2023-07-07 | 2023-07-07 |  |  |  |  | PP | DBT |  | 5.0 | Complete |  | COMPLETE | SI Test | Design, Build & Test (PIT) | T3-DB-0029 | SITAG | T3 |
| 227 | 1.3.6.3.1.2.3 | Elexon Central Systems Test Approach & Plan (PIT) V2 resubmitted to Programme for assurance | milestone, manual | 0d | 2023-07-27 A | 2023-07-27 A | 226FS+9d | 100% |  | 2023-07-27 | 2023-07-27 | 0d |  |  |  |  |  |  | PP | DBT |  | 5.4 | Complete |  | COMPLETE | SI Test | Design, Build & Test (PIT) |  |  |  |
| 228 | 1.3.6.3.1.2.4 | Elexon Central Systems Test Approach & Plan (PIT) V3 resubmitted to Programme for assurance | milestone | 0d | 2023-08-18 A | 2023-08-18 A | 227FS+17d | 100% |  | 2023-08-18 | 2023-08-18 | 0d |  |  |  |  |  |  | PP | DBT |  | 5.4 | Complete |  | COMPLETE | SI Test | Design, Build & Test (PIT) |  |  |  |
| 229 | 1.3.6.3.1.2.5 | Elexon Central Systems Test approach and plan MHHS Review Completed | milestone | 0d | 2023-09-22 A | 2023-09-22 A | 228FS+25d | 100% |  | 2023-09-22 | 2023-09-22 | 0d | 2023-07-10 | 2023-07-21 |  |  |  |  | SI Test | DBT |  | 5.8 | Complete |  | COMPLETE | PP | Design, Build & Test (PIT) | T3-DB-0106 | SITAG | T3 |

| ID | WBS | Task | Type | Duration | Start | Finish | Predecessors | Complete | Baseline start | Baseline finish | Baseline duration | Baseline 1 start | Baseline 1 finish | Constraint | Baseline cost | Responsible | Involved | Text9 | Update Version | MHHS Resource Name | MHHS Programme Phase | Sched Status | RAG | Artefact ID | Milestone ID | Text29 | Tier |
| --- | --- | --- | --- | --- | --- | --- | --- | --- | --- | --- | --- | --- | --- | --- | --- | --- | --- | --- | --- | --- | --- | --- | --- | --- | --- | --- | --- |
| 230 | 1.3.6.3.1.3 | **Test Readiness Report** |  | 16d | 2023-07-28 A | 2023-08-18 A |  | 100% | 2023-07-28 | 2023-08-18 | 51d | 2023-07-21 | 2023-09-29 |  |  | N/A | N/A | DBT | 5.0 | N/A | Design, Build & Test (PIT) |  |  |  |  |  |  |
| 231 | 1.3.6.3.1.3.1 | Test readiness reporting |  | 16d | 2023-07-28 A | 2023-08-18 A | 226FS+10d | 100% | 2023-07-28 | 2023-08-18 | 51d | 2023-07-21 | 2023-09-29 |  |  | PP | 109 | DBT | 5.0 |  | Design, Build & Test (PIT) | Complete | COMPLETE |  |  |  |  |
| 232 | 1.3.6.3.1.4 | **Requirements to test Traceability Matrix (RTTM)** |  | 35d | 2023-08-04 A | 2023-09-22 A |  | 100% | 2023-08-04 | 2023-09-22 | 35d | 2022-10-31 | 2023-08-18 |  | -0 | N/A | N/A | DBT | 5.0 | N/A | Design, Build & Test (PIT) |  |  |  |  |  |  |
| 233 | 1.3.6.3.1.4.1 | Elexon Central Systems RTTM submitted to Programme for assurance | milestone | 0d | 2023-08-04 A | 2023-08-04 A | 226 | 100% | 2023-08-04 | 2023-08-04 | 0d | 2023-08-04 | 2023-08-04 | start no earlier than 2023-04-28 |  | PP | SI Test | DBT | 5.0 |  | Design, Build & Test (PIT) | Complete | COMPLETE | MHHS-ART009 | T3-DB-0030 | SITAG | T3 |
| 234 | 1.3.6.3.1.4.2 | Elexon Central Systems RTTM MHHS Review Completed | milestone | 0d | 2023-09-22 A | 2023-09-22 A | 233FS+35d | 100% | 2023-09-22 | 2023-09-22 | 0d | 2023-08-07 | 2023-08-18 |  |  | SI Test | PP | DBT | 5.8 |  | Design, Build & Test (PIT) | Complete | COMPLETE |  | T3-DB-0107 | SITAG | T3 |
| 235 | 1.3.6.3.1.5 | **Test Scenarios** |  | 35d | 2023-08-04 A | 2023-09-22 A |  | 100% | 2023-08-04 | 2023-09-22 | 35d | 2022-10-31 | 2023-08-18 |  | -0 | N/A | N/A | DBT | 5.0 | N/A | Design, Build & Test (PIT) |  |  |  |  |  |  |
| 236 | 1.3.6.3.1.5.1 | Elexon Central Systems test scenarios submitted to Programme for assurance | milestone | 0d | 2023-08-04 A | 2023-08-04 A | 226 | 100% | 2023-08-04 | 2023-08-04 | 0d | 2023-08-04 | 2023-08-04 |  |  | PP | SI Test | DBT | 5.0 |  | Design, Build & Test (PIT) | Complete | COMPLETE |  | T3-DB-0032 | SITAG | T3 |
| 237 | 1.3.6.3.1.5.2 | Elexon Central Systems Test scenarios MHHS Review Completed | milestone | 0d | 2023-09-22 A | 2023-09-22 A | 236FS+35d | 100% | 2023-09-22 | 2023-09-22 | 0d | 2023-08-07 | 2023-08-18 |  |  | SI Test | PP | DBT | 5.8 |  | Design, Build & Test (PIT) | Complete | COMPLETE |  | T3-DB-0108 | SITAG | T3 |
| 238 | 1.3.6.3.1.6 | **PIT Execution** |  | 38d | 2023-08-21 A | 2023-10-11 A |  | 100% | 2023-08-21 | 2023-10-11 | 248d | 2022-10-31 | 2023-09-29 |  | -0 | N/A | N/A | DBT | 5.0 | N/A | Design, Build & Test (PIT) |  |  |  |  |  |  |
| 239 | 1.3.6.3.1.6.1 | PIT Test Execution Progress Report |  | 18d | 2023-09-04 A | 2023-09-27 A | 231FS+10d | 100% | 2023-09-04 | 2023-09-27 | 235d | 2022-10-31 | 2023-09-22 |  |  | PP | SI Test | DBT | 5.1 |  | Design, Build & Test (PIT) | Complete | COMPLETE |  |  |  |  |
| 240 | 1.3.6.3.1.6.2 | Elexon Central Systems PIT Execution |  | 28d | 2023-08-21 A | 2023-09-27 A | 231 | 100% | 2023-08-21 | 2023-09-27 | 240d | 2022-10-31 | 2023-09-29 |  |  | PP | SI Test | DBT | 5.1 |  | Design, Build & Test (PIT) | Complete | COMPLETE |  |  |  |  |
| 241 | 1.3.6.3.1.6.3 | Elexon Central Systems PIT Completion Report submitted to Programme for assurance | milestone | 0d | 2023-09-27 A | 2023-09-27 A | 240 | 100% | 2023-09-27 | 2023-09-27 | 0d | 2024-01-05 | 2024-01-05 |  |  | PP | SI Test | DBT | 5.8 |  | Design, Build & Test (PIT) | Complete | COMPLETE |  | T3-DB-0109 | SITAG | T3 |
| 242 | 1.3.6.3.1.6.4 | Elexon Central Systems PIT Completion Report MHHS Review Completed | milestone | 0d | 2023-10-11 A | 2023-10-11 A | 234, 237, 239, 241FS+10d, 229 | 100% | 2023-10-11 | 2023-10-11 | 0d |  |  |  |  | SI Test | PP | DBT | 5.8 |  | Design, Build & Test (PIT) | Complete | COMPLETE |  | T3-DB-0110 | SITAG | T3 |
| 243 | 1.3.6.3.2 | **DIP DBT CIT (Entering at Interval 1)** |  | 221d | 2023-01-02 A | 2023-11-06 A |  | 100% | 2023-01-02 | 2023-11-06 | 266d | 2022-10-31 | 2023-09-29 |  | -0 | N/A | N/A | DBT | 5.0 | N/A | Design, Build & Test (PIT) |  |  |  |  |  |  |
| 244 | 1.3.6.3.2.1 | Design |  | 80d | 2023-01-02 A | 2023-04-21 A |  | 100% | 2023-01-02 | 2023-04-21 | 80d | 2023-01-02 | 2023-04-21 | must start on 2023-01-02 |  | PP | SI Design | DBT | 5.0 |  | Design, Build & Test (PIT) | Complete | COMPLETE |  |  |  |  |
| 245 | 1.3.6.3.2.2 | Build |  | 155d | 2023-01-09 A | 2023-08-11 A | 244SS+5d | 100% | 2023-01-09 | 2023-08-11 | 155d | 2023-01-09 | 2023-08-11 |  |  | PP |  | DBT | 5.5 |  | Design, Build & Test (PIT) | Complete | COMPLETE |  |  |  |  |
| 246 | 1.3.6.3.2.3 | **Test Approach & Plan** |  | 9d | 2023-07-07 A | 2023-07-20 A |  | 100% | 2023-07-07 | 2023-07-20 | 190d | 2022-10-31 | 2023-07-21 |  |  | N/A | N/A | DBT | 5.0 | N/A | Design, Build & Test (PIT) |  |  |  |  |  |  |
| 247 | 1.3.6.3.2.3.1 | DIP Test Approach & Plan (PIT) submitted to Programme for assurance | milestone | 0d | 2023-07-07 A | 2023-07-07 A |  | 100% | 2023-07-07 | 2023-07-07 | 0d | 2023-07-07 | 2023-07-07 |  |  | PP | SI Test | DBT | 5.0 |  | Design, Build & Test (PIT) | Complete | COMPLETE | MHHS-ART073 | T3-DB-0026 | SITAG | T3 |
| 248 | 1.3.6.3.2.3.2 | DIP Test Approach & Plan (PIT) MHHS Review Completed | milestone | 0d | 2023-07-20 A | 2023-07-20 A | 247FS+9d | 100% | 2023-07-20 | 2023-07-20 | 10d | 2023-07-10 | 2023-07-21 |  |  | SI Test | PP | DBT | 5.0 |  | Design, Build & Test (PIT) | Complete | COMPLETE |  |  |  |  |
| 249 | 1.3.6.3.2.4 | **PIT Test Readiness Report** |  | 31d | 2023-07-21 A | 2023-09-01 A |  | 100% | 2023-07-21 | 2023-09-01 | 51d | 2023-07-21 | 2023-09-29 |  |  | N/A | N/A | DBT | 5.0 | N/A | Design, Build & Test (PIT) |  |  |  |  |  |  |
| 250 | 1.3.6.3.2.4.1 | Test readiness reporting |  | 31d | 2023-07-21 A | 2023-09-01 A | 247FS+9d | 100% | 2023-07-21 | 2023-09-01 | 51d | 2023-07-21 | 2023-09-29 |  |  | SI Test | 109 | DBT | 5.0 |  | Design, Build & Test (PIT) | Complete | COMPLETE |  |  |  |  |
| 251 | 1.3.6.3.2.5 | **Requirements to test Traceability Matrix (RTTM)** |  | 18d | 2023-08-04 A | 2023-08-30 A |  | 100% | 2023-08-04 | 2023-08-30 | 210d | 2022-10-31 | 2023-08-18 |  |  | N/A | N/A | DBT | 5.0 | N/A | Design, Build & Test (PIT) |  |  |  |  |  |  |
| 252 | 1.3.6.3.2.5.1 | DIP RTTM submitted to Programme for assurance | milestone | 0d | 2023-08-04 A | 2023-08-04 A | 247FS+15d | 100% | 2023-08-04 | 2023-08-04 | 0d | 2023-08-04 | 2023-08-04 |  |  | PP | SI Test | DBT | 5.6 |  | Design, Build & Test (PIT) | Complete | COMPLETE | MHHS-ART009 | T3-DB-0034 | SITAG | T3 |
| 253 | 1.3.6.3.2.5.2 | DIP RTTM MHHS Review Completed | milestone | 0d | 2023-08-30 A | 2023-08-30 A | 252FS+18d | 100% | 2023-08-30 | 2023-08-30 | 10d | 2023-08-07 | 2023-08-18 |  |  | SI Test | PP | DBT | 5.0 |  | Design, Build & Test (PIT) | Complete | COMPLETE |  |  |  |  |

Notes:
- 250: Action: 14/8 - Query from RG - IS this an SI Test deliverable or expected to be a DIP deliverable if so be more specific

| ID | WBS | Task | Type | Duration | Start | Finish | Predecessors | Complete | Baseline start | Baseline finish | Baseline duration | Baseline 1 start | Baseline 1 finish | Constraint | Baseline cost | Responsible | Involved | Text9 | Update Version | MHHS Resource Name | MHHS Programme Phase | Sched Status | RAG | Milestone ID | Text29 | Tier |
| --- | --- | --- | --- | --- | --- | --- | --- | --- | --- | --- | --- | --- | --- | --- | --- | --- | --- | --- | --- | --- | --- | --- | --- | --- | --- | --- |
| 254 | 1.3.6.3.2.6 | **Test Scenarios** |  | 22d | 2023-07-31 A | 2023-08-30 A |  | 100% | 2023-07-31 | 2023-08-30 | 206d | 2022-10-31 | 2023-08-18 |  |  | N/A | N/A | DBT | 5.0 | N/A | Design, Build & Test (PIT) |  |  |  |  |  |
| 255 | 1.3.6.3.2.6.1 | DIP PIT test scenarios submitted to Programme for assurance | milestone | 0d | 2023-07-31 A | 2023-07-31 A | 247FS+15d | 100% | 2023-07-31 | 2023-07-31 | 0d | 2023-08-04 | 2023-08-04 |  |  | PP | SI Test | DBT | 5.0 |  | Design, Build & Test (PIT) | Complete | COMPLETE | T3-DB-0036 | SITAG | T3 |
| 256 | 1.3.6.3.2.6.2 | DIP Test scenarios MHHS Review Completed | milestone | 0d | 2023-08-30 A | 2023-08-30 A | 255FS+22d | 100% | 2023-08-30 | 2023-08-30 | 10d | 2023-08-07 | 2023-08-18 |  |  | SI Test | PP | DBT | 5.0 |  | Design, Build & Test (PIT) | Complete | COMPLETE |  |  |  |
| 257 | 1.3.6.3.2.7 | **PIT execution** |  | 50d | 2023-08-29 A | 2023-11-06 A |  | 100% | 2023-08-29 | 2023-11-06 | 47d | 2022-10-31 | 2023-09-29 |  | -0 | N/A | N/A | DBT | 5.0 | N/A | Design, Build & Test (PIT) |  |  |  |  |  |
| 258 | 1.3.6.3.2.7.1 | PIT Test Execution Progress Report |  | 37d | 2023-09-01 A | 2023-10-23 A | 259FF, 250 | 100% | 2023-09-01 | 2023-10-23 | 37d | 2022-10-31 | 2023-09-22 | start no earlier than 2023-08-29 |  | PP | SI Test | DBT | 5.6 |  | Design, Build & Test (PIT) | Complete | COMPLETE |  |  |  |
| 259 | 1.3.6.3.2.7.2 | PIT Execution (Interim Release 1) |  | 30d | 2023-08-29 A | 2023-10-09 A |  | 100% | 2023-08-29 | 2023-10-09 | 24d | 2022-10-31 | 2023-09-29 | start no earlier than 2023-08-29 |  | PP | SI Test | DBT | 5.6 |  | Design, Build & Test (PIT) | Complete | COMPLETE |  |  |  |
| 260 | 1.3.6.3.2.7.3 | PIT Execution (Interim Release 2) |  | 10d | 2023-10-10 A | 2023-10-23 A | 259 | 100% | 2023-10-10 | 2023-10-23 | 10d |  |  |  |  | PP | SI Test | DBT | 5.6 |  | Design, Build & Test (PIT) | Complete | COMPLETE |  |  |  |
| 261 | 1.3.6.3.2.7.4 | DIP PIT Completion Report (Interim Release 1) submitted to Programme for assurance | milestone | 0d | 2023-10-09 A | 2023-10-09 A | 259 | 100% | 2023-10-09 | 2023-10-09 | 0d | 2024-01-05 | 2024-01-05 |  |  | PP | SI Test | DBT | 5.8 |  | Design, Build & Test (PIT) | Complete | COMPLETE | T3-DB-0111 | SITAG | T3 |
| 262 | 1.3.6.3.2.7.5 | DIP PIT Completion Report (Interim Release 1) MHHS Review Completed | milestone | 0d | 2023-10-23 A | 2023-10-23 A | 261FS+10d | 100% | 2023-10-23 | 2023-10-23 | 0d |  |  |  |  | SI Test | SI Test | DBT | 5.10 |  | Design, Build & Test (PIT) | Complete | COMPLETE | T3-DB-0112 | SITAG | T3 |
| 263 | 1.3.6.3.2.7.6 | DIP PIT Completion Report (Interim Release 2) submitted to Programme for assurance | milestone | 0d | 2023-10-23 A | 2023-10-23 A | 260, 258 | 100% | 2023-10-23 | 2023-10-23 | 0d | 2024-01-05 | 2024-01-05 |  |  | PP | SI Test | DBT | 5.10 |  | Design, Build & Test (PIT) | Complete | COMPLETE | T3-DB-0113 | SITAG | T3 |
| 264 | 1.3.6.3.2.7.7 | DIP PIT Completion Report (Interim Release 2) MHHS Review Completed | milestone | 0d | 2023-11-06 A | 2023-11-06 A | 263FS+10d | 100% | 2023-11-06 | 2023-11-06 | 0d |  |  |  |  | SI Test | SI Test | DBT | 5.14 |  | Design, Build & Test (PIT) | Complete | COMPLETE | T3-DB-0114 | SITAG | T3 |
| 265 | 1.3.6.3.3 | **DCC (DSP) DBT SIT Functional (Entering at SIT Functional)** |  | 325d | 2022-10-31 A | 2024-01-26 A |  | 100% | 2022-10-31 | 2024-01-26 | 345d | 2022-10-31 | 2024-01-05 |  | -0 | N/A | N/A | DBT | 5.18 | N/A | Design, Build & Test (PIT) |  |  |  |  |  |
| 266 | 1.3.6.3.3.1 | Design |  | 67d | 2022-10-31 A | 2023-01-31 A |  | 100% | 2022-10-31 | 2023-01-31 | 67d | 2022-10-31 | 2023-01-31 |  |  | PP | SI Design | DBT | 5.18 |  | Design, Build & Test (PIT) | Complete | COMPLETE |  |  |  |
| 267 | 1.3.6.3.3.2 | **Test Approach & Plan** |  | 20d | 2023-11-17 A | 2023-12-15 A |  | 100% | 2023-11-17 | 2023-12-15 | 20d | 2022-10-31 | 2023-10-27 |  | -0 | N/A | N/A | DBT | 5.18 | N/A | Design, Build & Test (PIT) |  |  |  |  |  |
| 268 | 1.3.6.3.3.2.1 | DCC Test Approach & Plan (PIT) submitted to Programme for assurance | milestone | 0d | 2023-11-17 A | 2023-11-17 A | 266FS+208d | 100% | 2023-11-17 | 2023-11-17 | 0d | 2023-10-13 | 2023-10-13 |  |  | PP | SI Test | DBT | 5.18 |  | Design, Build & Test (PIT) | Complete | COMPLETE | T3-DB-0068 | SITAG | T3 |
| 269 | 1.3.6.3.3.2.2 | DCC Test Approach & Plan (PIT) MHHS Review Completed | milestone | 0d | 2023-12-15 A | 2023-12-15 A | 268FS+20d | 100% | 2023-12-15 | 2023-12-15 | 0d | 2023-10-16 | 2023-10-27 |  |  | SI Test | PP | DBT | 5.18 |  | Design, Build & Test (PIT) | Complete | COMPLETE | T3-DB-0115 | SITAG | T3 |
| 270 | 1.3.6.3.3.3 | **Test Readiness Report** |  | 22d | 2023-12-04 A | 2024-01-02 A |  | 100% | 2023-12-04 | 2024-01-02 | 51d | 2023-10-27 | 2024-01-05 |  |  | N/A | N/A | DBT | 5.18 | N/A | Design, Build & Test (PIT) |  |  |  |  |  |
| 271 | 1.3.6.3.3.3.1 | Test readiness reporting |  | 22d | 2023-12-04 A | 2024-01-02 A | 268FS+10d | 100% | 2023-12-04 | 2024-01-02 | 51d | 2023-10-27 | 2024-01-05 |  |  | PP | 109 | DBT | 5.18 |  | Design, Build & Test (PIT) | Complete | COMPLETE |  |  |  |
| 272 | 1.3.6.3.3.4 | **Requirements to test Traceability Matrix (RTTM)** |  | 30d | 2023-12-15 A | 2024-01-26 A |  | 100% | 2023-12-15 | 2024-01-26 | 30d | 2022-10-31 | 2023-11-24 |  | -0 | N/A | N/A | DBT | 5.18 | N/A | Design, Build & Test (PIT) |  |  |  |  |  |
| 273 | 1.3.6.3.3.4.1 | DCC RTTM submitted to Programme for assurance | milestone | 0d | 2023-12-15 A | 2023-12-15 A | 268FS+20d | 100% | 2023-12-15 | 2023-12-15 | 0d | 2023-11-10 | 2023-11-10 | start no earlier than 2023-04-28 |  | PP | SI Test | DBT | 5.18 |  | Design, Build & Test (PIT) | Complete | COMPLETE | T3-DB-0074 | SITAG | T3 |
| 274 | 1.3.6.3.3.4.2 | DCC RTTM MHHS Review Completed | milestone | 0d | 2024-01-26 A | 2024-01-26 A | 273FS+30d | 100% | 2024-01-26 | 2024-01-26 | 0d | 2023-11-13 | 2023-11-24 |  |  | SI Test | PP | DBT | 5.18 |  | Design, Build & Test (PIT) | Complete | COMPLETE | T3-DB-0116 | SITAG | T3 |
| 275 | 1.3.6.3.3.5 | **Test Scenarios** |  | 30d | 2023-12-15 A | 2024-01-26 A |  | 100% | 2023-12-15 | 2024-01-26 | 30d | 2022-10-31 | 2023-11-24 |  | -0 | N/A | N/A | DBT | 5.18 | N/A | Design, Build & Test (PIT) |  |  |  |  |  |
| 276 | 1.3.6.3.3.5.1 | DCC test scenarios submitted to Programme for assurance | milestone | 0d | 2023-12-15 A | 2023-12-15 A | 268FS+20d | 100% | 2023-12-15 | 2023-12-15 | 0d | 2023-11-10 | 2023-11-10 |  |  | PP | SI Test | DBT | 5.18 |  | Design, Build & Test (PIT) | Complete | COMPLETE | T3-DB-0078 | SITAG | T3 |
| 277 | 1.3.6.3.3.5.2 | DCC Test Scenarios MHHS Review Completed | milestone | 0d | 2024-01-26 A | 2024-01-26 A | 276FS+30d | 100% | 2024-01-26 | 2024-01-26 | 0d | 2023-11-13 | 2023-11-24 |  |  | SI Test | PP | DBT | 5.18 |  | Design, Build & Test (PIT) | Complete | COMPLETE | T3-DB-0117 | SITAG | T3 |

Notes:
- 264: Guidance: 6/10 - LC - Successor should be SIT Component Integration Testing 1 Preparation Complete but not linked as DIP test completion plus 10 day review breaks logic. Decision will be made to proceed without a conclusion of the report review

| ID | WBS | Task | Type | Duration | Start | Finish | Predecessors | Complete | Baseline start | Baseline finish | Baseline duration | Baseline 1 start | Baseline 1 finish | Constraint | Baseline cost | Responsible | Involved | Text9 | Update Version | MHHS Resource Name | MHHS Programme Phase | Sched Status | RAG | Milestone ID | Text29 | Tier | Artefact ID |
| --- | --- | --- | --- | --- | --- | --- | --- | --- | --- | --- | --- | --- | --- | --- | --- | --- | --- | --- | --- | --- | --- | --- | --- | --- | --- | --- | --- |
| 278 | 1.3.6.3.4 | **RECCo (EES) DBT CIT (Entering at Interval 6)** |  | 71d | 2023-10-13 A | 2024-01-19 A |  | 100% | 2023-10-13 | 2024-01-19 | 320d | 2022-10-31 | 2024-01-05 |  | -0 | N/A | N/A | DBT | 5.0 | N/A | Design, Build & Test (PIT) |  |  |  |  |  |  |
| 279 | 1.3.6.3.4.1 | **Test Approach & Plan** |  | 20d | 2023-10-13 A | 2023-11-09 A |  | 100% | 2023-10-13 | 2023-11-09 | 20d | 2022-10-31 | 2023-10-27 |  | -0 | N/A | N/A | DBT | 5.0 | N/A | Design, Build & Test (PIT) |  |  |  |  |  |  |
| 280 | 1.3.6.3.4.1.1 | EES Test Approach & Plan (PIT) submitted to Programme for assurance | milestone | 0d | 2023-10-13 A | 2023-10-13 A |  | 100% | 2023-10-13 | 2023-10-13 | 0d | 2023-10-13 | 2023-10-13 | start no earlier than 2023-10-13 |  | PP | SI Test | DBT | 5.8 |  | Design, Build & Test (PIT) | Complete | COMPLETE | T3-DB-0066 | SITAG | T3 |  |
| 281 | 1.3.6.3.4.1.2 | EES Test approach and plan (PIT) MHHS Review Completed | milestone | 0d | 2023-11-09 A | 2023-11-09 A | 280FS+20d | 100% | 2023-11-09 | 2023-11-09 | 0d | 2023-10-16 | 2023-10-27 |  |  | SI Test | PP | DBT | 5.8 |  | Design, Build & Test (PIT) | Complete | COMPLETE | T3-DB-0119 | SITAG | T3 |  |
| 282 | 1.3.6.3.4.2 | **Test Readiness Report** |  | 10d | 2023-10-27 A | 2023-11-09 A |  | 100% | 2023-10-27 | 2023-11-09 | 51d | 2023-10-27 | 2024-01-05 |  |  | N/A | N/A | DBT | 5.0 | N/A | Design, Build & Test (PIT) |  |  |  |  |  |  |
| 283 | 1.3.6.3.4.2.1 | Test readiness reporting |  | 10d | 2023-10-27 A | 2023-11-09 A | 280FS+10d | 100% | 2023-10-27 | 2023-11-09 | 51d | 2023-10-27 | 2024-01-05 |  |  | PP | 109 | DBT | 5.0 |  | Design, Build & Test (PIT) | Complete | COMPLETE |  |  |  |  |
| 284 | 1.3.6.3.4.3 | **Requirements to test Traceability Matrix (RTTM)** |  | 20d | 2023-11-02 A | 2023-11-30 A |  | 100% | 2023-11-02 | 2023-11-30 | 20d | 2022-10-31 | 2023-11-24 |  | -0 | N/A | N/A | DBT | 5.0 | N/A | Design, Build & Test (PIT) |  |  |  |  |  |  |
| 285 | 1.3.6.3.4.3.1 | EES RTTM submitted to Programme for assurance | milestone | 0d | 2023-11-02 A | 2023-11-02 A | 280FS+15d | 100% | 2023-11-02 | 2023-11-02 | 0d | 2023-11-10 | 2023-11-10 |  |  | PP | SI Test | DBT | 5.8 |  | Design, Build & Test (PIT) | Complete | COMPLETE | T3-DB-0072 | SITAG | T3 | MHHS-ART009 |
| 286 | 1.3.6.3.4.3.2 | EES RTTM MHHS Review Completed | milestone | 0d | 2023-11-30 A | 2023-11-30 A | 285FS+20d | 100% | 2023-11-30 | 2023-11-30 | 0d | 2023-11-13 | 2023-11-24 |  |  | SI Test | PP | DBT | 5.14 |  | Design, Build & Test (PIT) | Complete | COMPLETE | T3-DB-0120 | SITAG | T3 |  |
| 287 | 1.3.6.3.4.4 | **Test Scenarios** |  | 20d | 2023-11-02 A | 2023-11-30 A |  | 100% | 2023-11-02 | 2023-11-30 | 20d | 2022-10-31 | 2023-11-24 |  | -0 | N/A | N/A | DBT | 5.0 | N/A | Design, Build & Test (PIT) |  |  |  |  |  |  |
| 288 | 1.3.6.3.4.4.1 | EES test scenarios submitted to Programme for assurance | milestone | 0d | 2023-11-02 A | 2023-11-02 A | 280FS+15d | 100% | 2023-11-02 | 2023-11-02 | 0d | 2023-11-10 | 2023-11-10 |  |  | PP | SI Test | DBT | 5.8 |  | Design, Build & Test (PIT) | Complete | COMPLETE | T3-DB-0031 | SITAG | T3 |  |
| 289 | 1.3.6.3.4.4.2 | EES Test scenarios MHHS Review Completed | milestone | 0d | 2023-11-30 A | 2023-11-30 A | 288FS+20d | 100% | 2023-11-30 | 2023-11-30 | 0d | 2023-11-13 | 2023-11-24 |  |  | SI Test | PP | DBT | 5.14 |  | Design, Build & Test (PIT) | Complete | COMPLETE | T3-DB-0121 | SITAG | T3 |  |
| 290 | 1.3.6.3.4.5 | **PIT execution** |  | 51d | 2023-11-10 A | 2024-01-19 A |  | 100% | 2023-11-10 | 2024-01-19 | 320d | 2022-10-31 | 2024-01-05 |  | -0 | N/A | N/A | DBT | 5.0 | N/A | Design, Build & Test (PIT) |  |  |  |  |  |  |
| 291 | 1.3.6.3.4.5.1 | PIT Test Execution Progress Report |  | 41d | 2023-11-10 A | 2024-01-05 A | 283 | 100% | 2023-11-10 | 2024-01-05 | 41d | 2022-10-31 | 2023-12-29 |  |  | PP | SI Test | DBT | 5.0 |  | Design, Build & Test (PIT) | Complete | COMPLETE |  |  |  |  |
| 292 | 1.3.6.3.4.5.2 | PIT Execution |  | 41d | 2023-11-10 A | 2024-01-05 A | 288FS+5d | 100% | 2023-11-10 | 2024-01-05 | 310d | 2022-10-31 | 2024-01-05 |  |  | PP | SI Test | DBT | 5.0 |  | Design, Build & Test (PIT) | Complete | COMPLETE |  |  |  |  |
| 293 | 1.3.6.3.4.5.3 | EES PIT Completion Report submitted to Programme for assurance | milestone | 0d | 2024-01-05 A | 2024-01-05 A | 291, 292 | 100% | 2024-01-05 | 2024-01-05 | 0d | 2024-01-05 | 2024-01-05 |  |  | PP | SI Test | DBT | 5.14 |  | Design, Build & Test (PIT) | Complete | COMPLETE | T3-DB-0122 | SITAG | T3 |  |
| 294 | 1.3.6.3.4.5.4 | EES PIT Completion Report MHHS Review Completed | milestone | 0d | 2024-01-19 A | 2024-01-19 A | 281, 286, 289, 293FS+10d | 100% | 2024-01-19 | 2024-01-19 | 0d |  |  |  |  | SI Test | PP | DBT | 5.14 |  | Design, Build & Test (PIT) | Complete | COMPLETE | T3-DB-0123 | SITAG | T3 |  |
| 295 | 1.3.6.3.5 | **Registration Services DBT CIT (Entering at Interval 2)** |  | 70d | 2023-07-28 A | 2023-11-03 A |  | 100% | 2023-07-28 | 2023-11-03 | 70d | 2022-10-31 | 2024-02-28 |  | -0 | N/A | N/A | DBT | 5.0 | N/A | Design, Build & Test (PIT) |  |  |  |  |  |  |
| 296 | 1.3.6.3.5.1 | **Test Approach & Plan** |  | 40d | 2023-07-28 A | 2023-09-22 A |  | 100% | 2023-07-28 | 2023-09-22 | 40d | 2022-10-31 | 2023-08-11 |  | -0 | N/A | N/A | DBT | 5.0 | N/A | Design, Build & Test (PIT) |  |  |  |  |  |  |
| 297 | 1.3.6.3.5.1.1 | Registration Services Test Approach & Plan (PIT) submitted to Programme for assurance | milestone | 0d | 2023-07-28 A | 2023-07-28 A |  | 100% | 2023-07-28 | 2023-07-28 | 0d | 2023-07-28 | 2023-07-28 |  |  | PP | SI Test | DBT | 5.0 |  | Design, Build & Test (PIT) | Complete | COMPLETE | T3-DB-0028 | SITAG | T3 | MHHS-ART073 |
| 298 | 1.3.6.3.5.1.2 | Registration Services Test approach and plan MHHS Review Completed | milestone | 0d | 2023-09-22 A | 2023-09-22 A | 297FS+40d | 100% | 2023-09-22 | 2023-09-22 | 0d | 2023-07-31 | 2023-08-11 |  |  | SI Test | PP | DBT | 5.8 |  | Design, Build & Test (PIT) | Complete | COMPLETE | T3-DB-0124 | SITAG | T3 |  |
| 299 | 1.3.6.3.5.2 | **Test Readiness Report** |  | 20d | 2023-08-14 A | 2023-09-08 A |  | 100% | 2023-08-14 | 2023-09-08 | 51d | 2023-08-11 | 2023-10-20 |  |  | N/A | N/A | DBT | 5.0 | N/A | Design, Build & Test (PIT) |  |  |  |  |  |  |
| 300 | 1.3.6.3.5.2.1 | Test readiness reporting |  | 20d | 2023-08-14 A | 2023-09-08 A | 297FS+10d | 100% | 2023-08-14 | 2023-09-08 | 51d | 2023-08-11 | 2023-10-20 |  |  | PP | 109 | DBT | 5.0 |  | Design, Build & Test (PIT) | Complete | COMPLETE |  |  |  |  |
| 301 | 1.3.6.3.5.3 | **Requirements to test Traceability Matrix (RTTM)** |  | 20d | 2023-09-01 A | 2023-09-29 A |  | 100% | 2023-09-01 | 2023-09-29 | 20d | 2022-10-31 | 2023-09-15 |  | -0 | N/A | N/A | DBT | 5.0 | N/A | Design, Build & Test (PIT) |  |  |  |  |  |  |
| 302 | 1.3.6.3.5.3.1 | Registration Services RTTM submitted to Programme for assurance | milestone | 0d | 2023-09-01 A | 2023-09-01 A | 297FS+15d | 100% | 2023-09-01 | 2023-09-01 | 0d | 2023-09-01 | 2023-09-01 | start no earlier than 2023-04-28 |  | PP | SI Test | DBT | 5.6 |  | Design, Build & Test (PIT) | Complete | COMPLETE | T3-DB-0042 | SITAG | T3 | MHHS-ART009 |
| 303 | 1.3.6.3.5.3.2 | Registration Services RTTM MHHS Review Completed | milestone | 0d | 2023-09-29 A | 2023-09-29 A | 302FS+20d | 100% | 2023-09-29 | 2023-09-29 | 0d | 2023-09-04 | 2023-09-15 |  |  | SI Test | PP | DBT | 5.8 |  | Design, Build & Test (PIT) | Complete | COMPLETE | T3-DB-0125 | SITAG | T3 |  |

| ID | WBS | Task | Type | Duration | Start | Finish | Predecessors | Complete | Remaining | Baseline start | Baseline finish | Baseline duration | Baseline 1 start | Baseline 1 finish | Total slack | Constraint | Baseline cost | Responsible | Involved | Text9 | Update Version | MHHS Resource Name | MHHS Programme Phase | Sched Status | RAG | Milestone ID | Text29 | Tier |
| --- | --- | --- | --- | --- | --- | --- | --- | --- | --- | --- | --- | --- | --- | --- | --- | --- | --- | --- | --- | --- | --- | --- | --- | --- | --- | --- | --- | --- |
| 304 | 1.3.6.3.5.4 | **Test Scenarios** |  | 20d | 2023-09-01 A | 2023-09-29 A |  | 100% |  | 2023-09-01 | 2023-09-29 | 20d | 2022-10-31 | 2023-09-15 |  |  | -0 | N/A | N/A | DBT | 5.0 | N/A | Design, Build & Test (PIT) |  |  |  |  |  |
| 305 | 1.3.6.3.5.4.1 | Registration Services test scenarios submitted to Programme for assurance | milestone | 0d | 2023-09-01 A | 2023-09-01 A | 297FS+15d | 100% |  | 2023-09-01 | 2023-09-01 | 0d | 2023-09-01 | 2023-09-01 |  |  |  | PP | SI Test | DBT | 5.6 |  | Design, Build & Test (PIT) | Complete | COMPLETE | T3-DB-0044 | SITAG | T3 |
| 306 | 1.3.6.3.5.4.2 | Registration Services Test scenarios MHHS Review Completed | milestone | 0d | 2023-09-29 A | 2023-09-29 A | 305FS+20d | 100% |  | 2023-09-29 | 2023-09-29 | 0d | 2023-09-04 | 2023-09-15 |  |  |  | SI Test | PP | DBT | 5.8 |  | Design, Build & Test (PIT) | Complete | COMPLETE | T3-DB-0126 | SITAG | T3 |
| 307 | 1.3.6.3.5.5 | **PIT execution** |  | 40d | 2023-09-11 A | 2023-11-03 A |  | 100% |  | 2023-09-11 | 2023-11-03 | 40d | 2023-01-02 | 2023-10-20 |  |  | -0 | N/A | N/A | DBT | 5.0 | N/A | Design, Build & Test (PIT) |  |  |  |  |  |
| 308 | 1.3.6.3.5.5.1 | PIT Test Execution Progress Report |  | 33d | 2023-09-11 A | 2023-10-25 A | 300 | 100% |  | 2023-09-11 | 2023-10-25 | 30d | 2023-01-02 | 2023-10-13 |  |  |  | PP | SI Test | DBT | 5.0 |  | Design, Build & Test (PIT) | Complete | COMPLETE |  |  |  |
| 309 | 1.3.6.3.5.5.2 | PIT Execution |  | 30d | 2023-09-11 A | 2023-10-20 A | 305FS+5d | 100% |  | 2023-09-11 | 2023-10-20 | 30d | 2023-01-16 | 2023-10-20 |  |  |  | PP | SI Test | DBT | 5.0 |  | Design, Build & Test (PIT) | Complete | COMPLETE |  |  |  |
| 310 | 1.3.6.3.5.5.3 | Registration Services PIT (CIT interval 2) Completion Report submitted to Programme for assurance | milestone | 0d | 2023-10-25 A | 2023-10-25 A | 308, 309 | 100% |  | 2023-10-25 | 2023-10-25 | 0d | 2024-01-05 | 2024-01-05 |  |  |  | PP | SI Test | DBT | 5.10 |  | Design, Build & Test (PIT) | Complete | COMPLETE | T3-DB-0127 | SITAG | T3 |
| 311 | 1.3.6.3.5.5.4 | Registration Services PIT (CIT interval 2) Completion Report MHHS Review Completed | milestone | 0d | 2023-11-03 A | 2023-11-03 A | 298, 303, 306, 310FS+7d | 100% |  | 2023-11-03 | 2023-11-03 | 0d |  |  |  |  |  | SI Test | PP | DBT | 5.11 |  | Design, Build & Test (PIT) | Complete | COMPLETE | T3-DB-0128 | SITAG | T3 |
| 312 | 1.3.6.4 | **SIT Participants DBT** |  | 401d | 2023-08-11 A | 2025-02-21 |  | 89% | 43.4d | 2023-08-11 | 2024-12-20 | 495d | 2022-10-31 | 2025-03-14 | 32307d |  | -0 | N/A | N/A | DBT | 5.0 | N/A | Design, Build & Test (PIT) |  |  |  |  |  |
| 313 | 1.3.6.4.1 | **All Data Services DBT CIT (Entering at Interval 3)** |  | 71d | 2023-08-11 A | 2023-11-17 A |  | 100% |  | 2023-08-11 | 2023-11-17 | 275d | 2022-10-31 | 2023-11-03 |  |  | -0 | N/A | N/A | DBT | 5.0 | N/A | Design, Build & Test (PIT) |  |  |  |  |  |
| 314 | 1.3.6.4.1.1 | **Test Approach & Plan** |  | 30d | 2023-08-11 A | 2023-09-21 A |  | 100% |  | 2023-08-11 | 2023-09-21 | 29d | 2022-10-31 | 2023-08-25 |  |  | -0 | N/A | N/A | DBT | 5.0 | N/A | Design, Build & Test (PIT) |  |  |  |  |  |
| 315 | 1.3.6.4.1.1.1 | All Data Services Test Approach & Plans (PIT) submitted to Programme for assurance | milestone | 0d | 2023-08-11 A | 2023-08-11 A |  | 100% |  | 2023-08-11 | 2023-08-11 | 0d | 2023-08-11 | 2023-08-11 |  | start no earlier than 2023-08-11 |  | PP | SI Test | DBT | 5.0 |  | Design, Build & Test (PIT) | Complete | COMPLETE | T3-DB-0038 | SITAG | T3 |
| 316 | 1.3.6.4.1.1.2 | All Data Services Test approach and plans MHHS Review Completed | milestone | 0d | 2023-09-21 A | 2023-09-21 A | 315FS+30d | 100% |  | 2023-09-21 | 2023-09-21 | 0d | 2023-08-14 | 2023-08-25 |  |  |  | SI Test | PP | DBT | 5.11 |  | Design, Build & Test (PIT) | Complete | COMPLETE | T3-DB-0129 | SITAG | T3 |
| 317 | 1.3.6.4.1.2 | **Test Readiness Report** |  | 11d | 2023-08-25 A | 2023-09-08 A |  | 100% |  | 2023-08-25 | 2023-09-08 | 11d | 2023-08-25 | 2023-11-03 |  |  | -0 | N/A | N/A | DBT | 5.0 | N/A | Design, Build & Test (PIT) |  |  |  |  |  |
| 318 | 1.3.6.4.1.2.1 | Test readiness reporting |  | 11d | 2023-08-25 A | 2023-09-08 A | 315FS+10d | 100% |  | 2023-08-25 | 2023-09-08 | 11d | 2023-08-25 | 2023-11-03 |  |  |  | PP | 109 | DBT | 5.0 |  | Design, Build & Test (PIT) | Complete | COMPLETE |  |  |  |
| 319 | 1.3.6.4.1.3 | **Requirements to test Traceability Matrix (RTTM)** |  | 7d | 2023-09-20 A | 2023-09-29 A |  | 100% |  | 2023-09-20 | 2023-09-29 | 5d | 2022-10-31 | 2023-10-06 |  |  | -0 | N/A | N/A | DBT | 5.0 | N/A | Design, Build & Test (PIT) |  |  |  |  |  |
| 320 | 1.3.6.4.1.3.1 | All Data Services RTTMs submitted to Programme for assurance | milestone | 0d | 2023-09-20 A | 2023-09-20 A | 315FS+29d | 100% |  | 2023-09-20 | 2023-09-20 | 0d | 2023-09-22 | 2023-09-22 |  |  |  | PP | SI Test | DBT | 5.7 |  | Design, Build & Test (PIT) | Complete | COMPLETE | T3-DB-0058 | SITAG | T3 |
| 321 | 1.3.6.4.1.3.2 | All Data Services RTTMs MHHS Review Completed | milestone | 0d | 2023-09-29 A | 2023-09-29 A | 320FS+7d | 100% |  | 2023-09-29 | 2023-09-29 | 0d | 2023-09-25 | 2023-10-06 |  |  |  | SI Test | PP | DBT | 5.8 |  | Design, Build & Test (PIT) | Complete | COMPLETE | T3-DB-0130 | SITAG | T3 |
| 322 | 1.3.6.4.1.4 | **Test Scenarios** |  | 6d | 2023-09-20 A | 2023-09-28 A |  | 100% |  | 2023-09-20 | 2023-09-28 | 4d | 2022-10-31 | 2023-10-06 |  |  | -0 | N/A | N/A | DBT | 5.0 | N/A | Design, Build & Test (PIT) |  |  |  |  |  |
| 323 | 1.3.6.4.1.4.1 | All Data Services test scenarios' submitted to Programme for assurance | milestone | 0d | 2023-09-20 A | 2023-09-20 A | 315FS+29d | 100% |  | 2023-09-20 | 2023-09-20 | 0d | 2023-09-22 | 2023-09-22 |  |  |  | PP | SI Test | DBT | 5.7 |  | Design, Build & Test (PIT) | Complete | COMPLETE | T3-DB-0056 | SITAG | T3 |
| 324 | 1.3.6.4.1.4.2 | All Data Services Test scenarios' MHHS Review Completed | milestone | 0d | 2023-09-28 A | 2023-09-28 A | 323FS+6d | 100% |  | 2023-09-28 | 2023-09-28 | 0d | 2023-09-25 | 2023-10-06 |  |  |  | SI Test | PP | DBT | 5.11 |  | Design, Build & Test (PIT) | Complete | COMPLETE | T3-DB-0131 | SITAG | T3 |
| 325 | 1.3.6.4.1.5 | **PIT execution** |  | 50d | 2023-09-11 A | 2023-11-17 A |  | 100% |  | 2023-09-11 | 2023-11-17 | 275d | 2022-10-31 | 2023-11-03 |  |  | -0 | N/A | N/A | DBT | 5.0 | N/A | Design, Build & Test (PIT) |  |  |  |  |  |
| 326 | 1.3.6.4.1.5.1 | PIT Test Execution Progress Report |  | 40d | 2023-09-11 A | 2023-11-03 A | 318 | 100% |  | 2023-09-11 | 2023-11-03 | 260d | 2022-10-31 | 2023-10-27 |  |  |  | PP | SI Test | DBT | 5.0 |  | Design, Build & Test (PIT) | Complete | COMPLETE |  |  |  |
| 327 | 1.3.6.4.1.5.2 | PIT Execution |  | 27d | 2023-09-28 A | 2023-11-03 A | 323FS+5d | 100% |  | 2023-09-28 | 2023-11-03 | 265d | 2022-10-31 | 2023-11-03 |  |  |  | PP | SI Test | DBT | 5.0 |  | Design, Build & Test (PIT) | Complete | COMPLETE |  |  |  |
| 328 | 1.3.6.4.1.5.3 | All Data Services PIT Completion Reports submitted to Programme for assurance | milestone | 0d | 2023-11-03 A | 2023-11-03 A | 326, 327 | 100% |  | 2023-11-03 | 2023-11-03 | 0d | 2024-01-05 | 2024-01-05 |  |  |  | PP | SI Test | DBT | 5.11 |  | Design, Build & Test (PIT) | Complete | COMPLETE | T3-DB-0132 | SITAG | T3 |
| 329 | 1.3.6.4.1.5.4 | All Data Services PIT Completion Reports MHHS Review Completed | milestone | 0d | 2023-11-17 A | 2023-11-17 A | 316, 321, 324, 328FS+10d | 100% |  | 2023-11-17 | 2023-11-17 | 0d |  |  |  |  |  | SI Test | PP | DBT | 5.13 |  | Design, Build & Test (PIT) | Complete | COMPLETE | T3-DB-0133 | SITAG | T3 |

| ID | WBS | Task | Type | Duration | Start | Finish | Predecessors | Complete | Remaining | Baseline start | Baseline finish | Baseline duration | Baseline 1 start | Baseline 1 finish | Total slack | Constraint | Baseline cost | Responsible | Involved | Text9 | Update Version | MHHS Resource Name | MHHS Programme Phase | Sched Status | RAG | Milestone ID | Text29 | Tier | Artefact ID |
| --- | --- | --- | --- | --- | --- | --- | --- | --- | --- | --- | --- | --- | --- | --- | --- | --- | --- | --- | --- | --- | --- | --- | --- | --- | --- | --- | --- | --- | --- |
| 330 | 1.3.6.4.2 | **All Metering Services DBT CIT (Entering at Interval 4)** |  | 70d | 2023-08-25 A | 2023-12-01 A |  | 100% |  | 2023-08-25 | 2023-12-01 | 285d | 2022-10-31 | 2023-11-17 |  |  | -0 | N/A | N/A | DBT | 5.0 | N/A | Design, Build & Test (PIT) |  |  |  |  |  |  |
| 331 | 1.3.6.4.2.1 | **Test Approach & Plan** |  | 40d | 2023-08-25 A | 2023-10-20 A |  | 100% |  | 2023-08-25 | 2023-10-20 | 40d | 2022-10-31 | 2023-09-08 |  |  | -0 | N/A | N/A | DBT | 5.0 | N/A | Design, Build & Test (PIT) |  |  |  |  |  |  |
| 332 | 1.3.6.4.2.1.1 | All Metering Services Test Approach & Plans (PIT) submitted to Programme for assurance | milestone | 0d | 2023-08-25 A | 2023-08-25 A |  | 100% |  | 2023-08-25 | 2023-08-25 | 0d | 2023-08-25 | 2023-08-25 |  |  |  | PP | SI Test | DBT | 5.6 |  | Design, Build & Test (PIT) | Complete | COMPLETE | T3-DB-0040 | SITAG | T3 |  |
| 333 | 1.3.6.4.2.1.2 | All Metering Services Test approach and plans MHHS Review Completed | milestone | 0d | 2023-10-20 A | 2023-10-20 A | 332FS+40d | 100% |  | 2023-10-20 | 2023-10-20 | 0d | 2023-08-28 | 2023-09-08 |  |  |  | SI Test | PP | DBT | 5.8 |  | Design, Build & Test (PIT) | Complete | COMPLETE | T3-DB-0134 | SITAG | T3 |  |
| 334 | 1.3.6.4.2.2 | **Test Readiness Report** |  | 11d | 2023-09-11 A | 2023-09-25 A |  | 100% |  | 2023-09-11 | 2023-09-25 | 51d | 2023-09-08 | 2023-11-17 |  |  |  | N/A | N/A | DBT | 5.0 | N/A | Design, Build & Test (PIT) |  |  |  |  |  |  |
| 335 | 1.3.6.4.2.2.1 | Test readiness reporting |  | 11d | 2023-09-11 A | 2023-09-25 A | 332FS+10d | 100% |  | 2023-09-11 | 2023-09-25 | 51d | 2023-09-08 | 2023-11-17 |  |  |  | PP | 109 | DBT | 5.0 |  | Design, Build & Test (PIT) | Complete | COMPLETE |  |  |  |  |
| 336 | 1.3.6.4.2.3 | **Requirements to test Traceability Matrix (RTTM)** |  | 30d | 2023-09-15 A | 2023-10-27 A |  | 100% |  | 2023-09-15 | 2023-10-27 | 30d | 2022-10-31 | 2023-09-29 |  |  | -0 | N/A | N/A | DBT | 5.0 | N/A | Design, Build & Test (PIT) |  |  |  |  |  |  |
| 337 | 1.3.6.4.2.3.1 | All Metering Services RTTMs submitted to Programme for assurance | milestone | 0d | 2023-09-15 A | 2023-09-15 A | 332FS+15d | 100% |  | 2023-09-15 | 2023-09-15 | 0d | 2023-09-15 | 2023-09-15 |  |  |  | PP | SI Test | DBT | 5.8 |  | Design, Build & Test (PIT) | Complete | COMPLETE | T3-DB-0048 | SITAG | T3 | MHHS-ART009 |
| 338 | 1.3.6.4.2.3.2 | All Metering Services MHHS Reviews Completed | milestone | 0d | 2023-10-27 A | 2023-10-27 A | 337FS+30d | 100% |  | 2023-10-27 | 2023-10-27 | 0d | 2023-09-18 | 2023-09-29 |  |  |  | SI Test | PP | DBT | 5.13 |  | Design, Build & Test (PIT) | Complete | COMPLETE | T3-DB-0135 | SITAG | T3 |  |
| 339 | 1.3.6.4.2.4 | **Test Scenarios** |  | 30d | 2023-09-15 A | 2023-10-27 A |  | 100% |  | 2023-09-15 | 2023-10-27 | 30d | 2022-10-31 | 2023-09-29 |  |  | -0 | N/A | N/A | DBT | 5.0 | N/A | Design, Build & Test (PIT) |  |  |  |  |  |  |
| 340 | 1.3.6.4.2.4.1 | All Metering Services test scenarios' submitted to Programme for assurance | milestone | 0d | 2023-09-15 A | 2023-09-15 A | 332FS+15d | 100% |  | 2023-09-15 | 2023-09-15 | 0d | 2023-09-15 | 2023-09-15 |  |  |  | PP | SI Test | DBT | 5.8 |  | Design, Build & Test (PIT) | Complete | COMPLETE | T3-DB-0050 | SITAG | T3 |  |
| 341 | 1.3.6.4.2.4.2 | All Metering Services Test scenarios' MHHS Review Completed | milestone | 0d | 2023-10-27 A | 2023-10-27 A | 340FS+30d | 100% |  | 2023-10-27 | 2023-10-27 | 0d | 2023-09-18 | 2023-09-29 |  |  |  | SI Test | PP | DBT | 5.13 |  | Design, Build & Test (PIT) | Complete | COMPLETE | T3-DB-0136 | SITAG | T3 |  |
| 342 | 1.3.6.4.2.5 | **PIT execution** |  | 50d | 2023-09-25 A | 2023-12-01 A |  | 100% |  | 2023-09-25 | 2023-12-01 | 285d | 2022-10-31 | 2023-11-17 |  |  | -0 | N/A | N/A | DBT | 5.0 | N/A | Design, Build & Test (PIT) |  |  |  |  |  |  |
| 343 | 1.3.6.4.2.5.1 | PIT Test Execution Progress Report |  | 39d | 2023-09-26 A | 2023-11-17 A | 335 | 100% |  | 2023-09-26 | 2023-11-17 | 39d | 2022-10-31 | 2023-11-10 |  |  |  | PP | SI Test | DBT | 5.0 |  | Design, Build & Test (PIT) | Complete | COMPLETE |  |  |  |  |
| 344 | 1.3.6.4.2.5.2 | PIT Execution |  | 40d | 2023-09-25 A | 2023-11-17 A | 340FS+5d | 100% |  | 2023-09-25 | 2023-11-17 | 275d | 2022-10-31 | 2023-11-17 |  |  |  | PP | SI Test | DBT | 5.0 |  | Design, Build & Test (PIT) | Complete | COMPLETE |  |  |  |  |
| 345 | 1.3.6.4.2.5.3 | All Metering Services PIT Completion Reports submitted to Programme for assurance | milestone | 0d | 2023-11-17 A | 2023-11-17 A | 343, 344 | 100% |  | 2023-11-17 | 2023-11-17 | 0d | 2024-01-05 | 2024-01-05 |  |  |  | PP | SI Test | DBT | 5.13 |  | Design, Build & Test (PIT) | Complete | COMPLETE | T3-DB-0137 | SITAG | T3 |  |
| 346 | 1.3.6.4.2.5.4 | All Metering Services PIT Completion Reports MHHS Review Completed | milestone | 0d | 2023-12-01 A | 2023-12-01 A | 333, 338, 341, 345FS+10d | 100% |  | 2023-12-01 | 2023-12-01 | 0d |  |  |  |  |  | SI Test | PP | DBT | 5.13 |  | Design, Build & Test (PIT) | Complete | COMPLETE | T3-DB-0138 | SITAG | T3 |  |
| 347 | 1.3.6.4.3 | **All SIT Programme Participants PIT (SIT Functional)** |  | 331d | 2023-11-17 A | 2025-02-21 |  | 77% | 77.15d | 2023-11-17 | 2024-12-20 | 451d | 2022-12-30 | 2024-02-16 | 32307d |  | -0 | N/A | N/A | DBT | 5.0 | N/A | Design, Build & Test (PIT) |  |  |  |  |  |  |
| 348 | 1.3.6.4.3.1 | **Test Approach & Plans** |  | 40d | 2023-11-17 A | 2024-01-11 A |  | 100% |  | 2023-11-17 | 2024-01-11 | 40d | 2022-12-30 | 2023-11-30 |  |  | -0 | N/A | N/A | DBT | 5.2 | N/A | Design, Build & Test (PIT) |  |  |  |  |  |  |
| 349 | 1.3.6.4.3.1.1 | SIT Functional PIT Test Approach & Plan (PIT) submitted to Programme for assurance | milestone | 0d | 2023-11-17 A | 2023-11-17 A |  | 100% |  | 2023-11-17 | 2023-11-17 | 0d | 2023-11-16 | 2023-11-16 |  | start no earlier than 2023-11-17 |  | PP | SI Test | DBT | 5.16 |  | Design, Build & Test (PIT) | Complete | COMPLETE | T3-DB-0093 | SITAG | T3 |  |
| 350 | 1.3.6.4.3.1.2 | All SIT Functional Test approach and plans MHHS Reviews Completed | milestone | 0d | 2024-01-11 A | 2024-01-11 A | 349FS+40d | 100% |  | 2024-01-11 | 2024-01-11 | 0d | 2023-11-17 | 2023-11-30 |  |  |  | SI Test | PP | DBT | 5.8 |  | Design, Build & Test (PIT) | Complete | COMPLETE | T3-DB-0139 | SITAG | T3 |  |
| 351 | 1.3.6.4.3.2 | **Test Readiness Reports** |  | 11d | 2023-12-01 A | 2023-12-15 A |  | 100% |  | 2023-12-01 | 2023-12-15 | 51d | 2023-11-30 | 2024-02-08 |  |  |  | N/A | N/A | DBT | 5.2 | N/A | Design, Build & Test (PIT) |  |  |  |  |  |  |
| 352 | 1.3.6.4.3.2.1 | Test readiness reporting |  | 11d | 2023-12-01 A | 2023-12-15 A | 349FS+10d | 100% |  | 2023-12-01 | 2023-12-15 | 51d | 2023-11-30 | 2024-02-08 |  |  |  | PP | 109 | DBT | 5.2 |  | Design, Build & Test (PIT) | Complete | COMPLETE |  |  |  |  |
| 353 | 1.3.6.4.3.3 | **Requirements to test Traceability Matrices (RTTM)** |  | 30d | 2023-12-07 A | 2024-01-18 A |  | 100% |  | 2023-12-07 | 2024-01-18 | 30d | 2023-01-06 | 2024-01-05 |  |  | -0 | N/A | N/A | DBT | 5.2 | N/A | Design, Build & Test (PIT) |  |  |  |  |  |  |
| 354 | 1.3.6.4.3.3.1 | SIT Functional PIT RTTM submitted to Programme for assurance | milestone | 0d | 2023-12-07 A | 2023-12-07 A | 349FS+15d | 100% |  | 2023-12-07 | 2023-12-07 | 0d | 2023-12-14 | 2023-12-14 |  |  |  | PP | SI Test | DBT | 5.14 |  | Design, Build & Test (PIT) | Complete | COMPLETE | T3-DB-0091 | SITAG | T3 |  |
| 355 | 1.3.6.4.3.3.2 | All SIT Functional RTTMs MHHS Reviews Completed | milestone | 0d | 2024-01-18 A | 2024-01-18 A | 354FS+30d | 100% |  | 2024-01-18 | 2024-01-18 | 0d | 2023-12-15 | 2024-01-05 |  |  |  | SI Test | PP | DBT | 5.14 |  | Design, Build & Test (PIT) | Complete | COMPLETE | T3-DB-0140 | SITAG | T3 |  |

| ID | WBS | Task | Type | Duration | Start | Finish | Predecessors | Complete | Baseline start | Baseline finish | Baseline duration | Baseline 1 start | Baseline 1 finish | Constraint | Baseline cost | Responsible | Involved | Text9 | Update Version | MHHS Resource Name | MHHS Programme Phase | Sched Status | RAG | Milestone ID | Text29 | Tier |
| --- | --- | --- | --- | --- | --- | --- | --- | --- | --- | --- | --- | --- | --- | --- | --- | --- | --- | --- | --- | --- | --- | --- | --- | --- | --- | --- |
| 356 | 1.3.6.4.3.4 | **Test Scenarios** |  | 30d | 2023-12-07 A | 2024-01-18 A |  | 100% | 2023-12-07 | 2024-01-18 | 30d | 2023-01-06 | 2024-01-05 |  | -0 | N/A | N/A | DBT | 5.2 | N/A | Design, Build & Test (PIT) |  |  |  |  |  |
| 357 | 1.3.6.4.3.4.1 | SIT Functional PIT test scenarios submitted to Programme for assurance | milestone | 0d | 2023-12-07 A | 2023-12-07 A | 349FS+15d | 100% | 2023-12-07 | 2023-12-07 | 0d | 2023-12-14 | 2023-12-14 |  |  | PP | SI Test | DBT | 5.14 |  | Design, Build & Test (PIT) | Complete | COMPLETE | T3-DB-0089 | SITAG | T3 |
| 358 | 1.3.6.4.3.4.2 | All SIT Functional Test scenarios' MHHS Reviews Completed | milestone | 0d | 2024-01-18 A | 2024-01-18 A | 357FS+30d | 100% | 2024-01-18 | 2024-01-18 | 0d | 2023-12-15 | 2024-01-05 |  |  | SI Test | PP | DBT | 5.14 |  | Design, Build & Test (PIT) | Complete | COMPLETE | T3-DB-0141 | SITAG | T3 |
| 359 | 1.3.6.4.3.5 | **PIT execution** |  | 51d | 2023-12-15 A | 2024-02-23 A |  | 100% | 2023-12-15 | 2024-02-23 | 301d | 2022-12-30 | 2024-02-09 |  | -0 | N/A | N/A | DBT | 5.0 | N/A | Design, Build & Test (PIT) |  |  |  |  |  |
| 360 | 1.3.6.4.3.5.1 | PIT Test Execution Progress Reports |  | 40d | 2023-12-18 A | 2024-02-09 A | 352 | 100% | 2023-12-18 | 2024-02-09 | 40d | 2022-12-30 | 2024-02-01 |  |  | PP | SI Test | DBT | 5.0 |  | Design, Build & Test (PIT) | Complete | COMPLETE |  |  |  |
| 361 | 1.3.6.4.3.5.2 | PIT Execution |  | 41d | 2023-12-15 A | 2024-02-09 A | 357FS+5d | 100% | 2023-12-15 | 2024-02-09 | 290d | 2022-12-30 | 2024-02-09 |  |  | PP | SI Test | DBT | 5.0 |  | Design, Build & Test (PIT) | Complete | COMPLETE |  |  |  |
| 362 | 1.3.6.4.3.5.3 | All SIT Functional PIT Completion Reports submitted to Programme for Assurance | milestone | 0d | 2024-02-09 A | 2024-02-09 A | 360, 361 | 100% | 2024-02-09 | 2024-02-09 | 0d | 2024-01-05 | 2024-01-05 |  |  | PP | SI Test | DBT | 5.19 |  | Design, Build & Test (PIT) | Complete | COMPLETE | T3-DB-0087 | SITAG | T3 |
| 363 | 1.3.6.4.3.5.4 | All SIT Functional PIT Completion Reports MHHS Review Completed | milestone | 0d | 2024-02-23 A | 2024-02-23 A | 350, 355, 358, 362FS+10d | 100% | 2024-02-23 | 2024-02-23 | 0d |  |  |  |  | SI Test | PP | DBT | 5.19 |  | Design, Build & Test (PIT) | Complete | COMPLETE | T3-DB-0142 | SITAG | T3 |
| 364 | 1.3.6.4.3.6 | **All SIT Programme Participants PIT (SIT Migration)** |  | 71d | 2024-02-16 A | 2024-05-24 A |  | 100% | 2024-02-16 | 2024-05-24 | 301d |  |  |  | -0 | N/A | N/A | DBT | 5.1 | N/A | Design, Build & Test (PIT) |  |  |  |  |  |
| 365 | 1.3.6.4.3.6.1 | **Test Approach & Plans** |  | 40d | 2024-02-16 A | 2024-04-11 A |  | 100% | 2024-02-16 | 2024-04-11 | 40d |  |  |  | -0 | N/A | N/A | DBT | 5.2 | N/A | Design, Build & Test (PIT) |  |  |  |  |  |
| 366 | 1.3.6.4.3.6.1.1 | All SIT Migration PIT Test Approach & Plans submitted to Programme for assurance | milestone | 0d | 2024-02-16 A | 2024-02-16 A |  | 100% | 2024-02-16 | 2024-02-16 | 0d |  |  | start no earlier than 2024-02-16 |  | PP | SI Test | DBT | 5.8 |  | Design, Build & Test (PIT) | Complete | COMPLETE | T3-DB-0143 | SITAG | T3 |
| 367 | 1.3.6.4.3.6.1.2 | All SIT Migration PIT Test approach and plans MHHS Reviews Completed | milestone | 0d | 2024-04-11 A | 2024-04-11 A | 366FS+40d | 100% | 2024-04-11 | 2024-04-11 | 0d |  |  |  |  | SI Test | PP | DBT | 5.23 |  | Design, Build & Test (PIT) | Complete | COMPLETE | T3-DB-0144 | SITAG | T3 |
| 368 | 1.3.6.4.3.6.2 | **Test Readiness Reports** |  | 11d | 2024-03-01 A | 2024-03-15 A |  | 100% | 2024-03-01 | 2024-03-15 | 51d |  |  |  |  | N/A | N/A | DBT | 5.2 | N/A | Design, Build & Test (PIT) |  |  |  |  |  |
| 369 | 1.3.6.4.3.6.2.1 | Test readiness reporting |  | 11d | 2024-03-01 A | 2024-03-15 A | 366FS+10d | 100% | 2024-03-01 | 2024-03-15 | 51d |  |  |  |  | PP | 109 | DBT | 5.2 |  | Design, Build & Test (PIT) | Complete | COMPLETE |  |  |  |
| 370 | 1.3.6.4.3.6.3 | **Requirements to test Traceability Matrices (RTTM)** |  | 30d | 2024-03-07 A | 2024-04-18 A |  | 100% | 2024-03-07 | 2024-04-18 | 30d |  |  |  | -0 | N/A | N/A | DBT | 5.2 | N/A | Design, Build & Test (PIT) |  |  |  |  |  |
| 371 | 1.3.6.4.3.6.3.1 | All SIT Migration PIT RTTMs submitted to Programme for assurance | milestone | 0d | 2024-03-07 A | 2024-03-07 A | 366FS+15d | 100% | 2024-03-07 | 2024-03-07 | 0d |  |  |  |  | PP | SI Test | DBT | 5.23 |  | Design, Build & Test (PIT) | Complete | COMPLETE | T3-DB-0145 | SITAG | T3 |
| 372 | 1.3.6.4.3.6.3.2 | All SIT Migration RTTMs MHHS Reviews Completed | milestone | 0d | 2024-04-18 A | 2024-04-18 A | 371FS+30d | 100% | 2024-04-18 | 2024-04-18 | 0d |  |  |  |  | SI Test | PP | DBT | 5.25 |  | Design, Build & Test (PIT) | Complete | COMPLETE | T3-DB-0146 | SITAG | T3 |
| 373 | 1.3.6.4.3.6.4 | **Test Scenarios** |  | 30d | 2024-03-07 A | 2024-04-18 A |  | 100% | 2024-03-07 | 2024-04-18 | 30d |  |  |  | -0 | N/A | N/A | DBT | 5.2 | N/A | Design, Build & Test (PIT) |  |  |  |  |  |
| 374 | 1.3.6.4.3.6.4.1 | All SIT Migration PIT test scenarios submitted to Programme for assurance | milestone | 0d | 2024-03-07 A | 2024-03-07 A | 366FS+15d | 100% | 2024-03-07 | 2024-03-07 | 0d |  |  |  |  | PP | SI Test | DBT | 5.23 |  | Design, Build & Test (PIT) | Complete | COMPLETE | T3-DB-0147 | SITAG | T3 |
| 375 | 1.3.6.4.3.6.4.2 | All SIT Migration Test scenarios MHHS Reviews Completed | milestone | 0d | 2024-04-18 A | 2024-04-18 A | 374FS+30d | 100% | 2024-04-18 | 2024-04-18 | 0d |  |  |  |  | SI Test | PP | DBT | 5.25 |  | Design, Build & Test (PIT) | Complete | COMPLETE | T3-DB-0148 | SITAG | T3 |
| 376 | 1.3.6.4.3.6.5 | **PIT execution** |  | 51d | 2024-03-15 A | 2024-05-24 A |  | 100% | 2024-03-15 | 2024-05-24 | 301d |  |  |  | -0 | N/A | N/A | DBT | 5.1 | N/A | Design, Build & Test (PIT) |  |  |  |  |  |
| 377 | 1.3.6.4.3.6.5.1 | PIT Test Execution Progress Reports |  | 40d | 2024-03-18 A | 2024-05-10 A | 369 | 100% | 2024-03-18 | 2024-05-10 | 40d |  |  |  |  | PP | SI Test | DBT | 5.1 |  | Design, Build & Test (PIT) | Complete | COMPLETE |  |  |  |
| 378 | 1.3.6.4.3.6.5.2 | PIT Execution |  | 41d | 2024-03-15 A | 2024-05-10 A | 374FS+5d | 100% | 2024-03-15 | 2024-05-10 | 290d |  |  |  |  | PP | SI Test | DBT | 5.1 |  | Design, Build & Test (PIT) | Complete | COMPLETE |  |  |  |
| 379 | 1.3.6.4.3.6.5.3 | All SIT Migration PIT Completion Reports submitted to Programme for assurance | milestone | 0d | 2024-05-10 A | 2024-05-10 A | 377, 378 | 100% | 2024-05-10 | 2024-05-10 | 0d | 2024-01-05 | 2024-01-05 |  |  | PP | SI Test | DBT | 5.8 |  | Design, Build & Test (PIT) | Complete | COMPLETE | T3-DB-0149 | SITAG | T3 |
| 380 | 1.3.6.4.3.6.5.4 | All SIT Migration PIT Completion Reports MHHS Review Completed | milestone | 0d | 2024-05-24 A | 2024-05-24 A | 367, 372, 375, 379FS+10d | 100% | 2024-05-24 | 2024-05-24 | 0d |  |  |  |  | SI Test | PP | DBT | 5.8 |  | Design, Build & Test (PIT) | Complete | COMPLETE | T3-DB-0150 | SITAG | T3 |

| ID | WBS | Task | Type | Duration | Start | Finish | Predecessors | Complete | Remaining | Baseline start | Baseline finish | Baseline duration | Baseline 1 start | Baseline 1 finish | Total slack | Free slack | Constraint | Baseline cost | Responsible | Involved | Text9 | Update Version | MHHS Resource Name | MHHS Programme Phase | Sched Status | RAG | Milestone ID | Text29 | Tier | Guidance | Task Status |
| --- | --- | --- | --- | --- | --- | --- | --- | --- | --- | --- | --- | --- | --- | --- | --- | --- | --- | --- | --- | --- | --- | --- | --- | --- | --- | --- | --- | --- | --- | --- | --- |
| 381 | 1.3.6.4.3.7 | **All SIT Programme Participants PIT (SIT Non Functional)** |  | 161d | 2024-07-12 A | 2025-02-21 |  | 63% | 59.63d | 2024-07-12 | 2024-12-20 | 301d |  |  | 32307d |  |  | -0 | N/A | N/A | DBT | 6.0 | N/A | Design, Build & Test (PIT) |  |  |  |  |  |  |  |
| 382 | 1.3.6.4.3.7.1 | **Test Approach & Plan** |  | 41d | 2024-09-27 A | 2024-11-22 |  |  | 41d | 2024-09-27 | 2024-11-22 | 40d |  |  | 31630d |  |  | -0 | N/A | N/A | DBT | 6.0 | N/A | Design, Build & Test (PIT) |  |  |  |  |  |  |  |
| 383 | 1.3.6.4.3.7.1.1 | SIT Non-Functional PIT Test Approach & Plan (PIT) submitted to Programme for assurance | milestone | 0d | 2024-09-27 A | 2024-09-27 A |  | 100% |  | 2024-09-27 | 2024-09-27 | 0d |  |  |  |  | start no earlier than 2024-05-10 |  | PP | SI Test | DBT | 6.0 | Roger Robar | Design, Build & Test (PIT) | Complete | COMPLETE | T3-DB-0151 | SITAG | T3 |  |  |
| 384 | 1.3.6.4.3.7.1.2 | SIT Non-Functional Test approach and plan MHHS Review Completed |  | 1d | 2024-11-21 A | 2024-11-22 | 383FS+40d |  | 1d | 2024-11-21 | 2024-11-22 | 0d |  |  | 31630d | 20d |  |  | SI Test | PP | DBT | 6.0 | Roger Robar | Design, Build & Test (PIT) | Green | RED | T3-DB-0152 | SITAG | T3 | 6/9/24: Approved at esitag on 26/7/24 | -28.67 |
| 385 | 1.3.6.4.3.7.2 | **Test Readiness Report** |  | 13d | 2024-10-04 A | 2024-10-22 |  | 85% | 2d | 2024-10-04 | 2024-10-22 | 51d |  |  | 0d |  |  |  | N/A | N/A | DBT | 6.0 | N/A | Design, Build & Test (PIT) |  |  |  |  |  |  |  |
| 386 | 1.3.6.4.3.7.2.1 | Test readiness reporting |  | 13d | 2024-10-04 A | 2024-10-22 | 383FS+10d | 85% | 2d | 2024-10-04 | 2024-10-22 | 51d |  |  | 0d |  |  |  | PP | 109 | DBT | 6.0 |  | Design, Build & Test (PIT) | Green | RED |  |  |  |  |  |
| 387 | 1.3.6.4.3.7.3 | **Requirements to test Traceability Matrix (RTTM)** |  | 20d | 2024-11-01 A | 2024-11-29 |  |  | 20d | 2024-11-01 | 2024-11-29 | 30d |  |  | 31625d |  |  | -0 | N/A | N/A | DBT | 6.0 | N/A | Design, Build & Test (PIT) |  |  |  |  |  |  |  |
| 388 | 1.3.6.4.3.7.3.1 | SIT Non-Functional PIT RTTM submitted to Programme for assurance | milestone | 0d | 2024-11-01 A | 2024-11-01 A | 383FS+26d | 100% |  | 2024-11-01 | 2024-11-01 | 0d |  |  |  |  |  |  | PP | SI Test | DBT | 6.0 | Roger Robar | Design, Build & Test (PIT) | Complete | COMPLETE | T3-DB-0153 | SITAG | T3 |  |  |
| 389 | 1.3.6.4.3.7.3.2 | SIT Non-Functional RTTM MHHS Review Completed | milestone | 0d | 2024-11-29 | 2024-11-29 | 388FS+20d |  |  | 2024-11-29 | 2024-11-29 | 0d |  |  | 31738d | 15d | start no earlier than 2024-11-29 |  | SI Test | PP | DBT | 6.0 | Roger Robar | Design, Build & Test (PIT) | Green | RED | T3-DB-0154 | SITAG | T3 |  | -20.29 |
| 390 | 1.3.6.4.3.7.4 | **Test Scenarios** |  | 20d | 2024-11-01 A | 2024-11-29 |  |  | 20d | 2024-11-01 | 2024-11-29 | 30d |  |  | 31625d |  |  | -0 | N/A | N/A | DBT | 6.0 | N/A | Design, Build & Test (PIT) |  |  |  |  |  |  |  |
| 391 | 1.3.6.4.3.7.4.1 | SIT Non-Functional PIT test scenarios submitted to Programme for assurance | milestone | 0d | 2024-11-01 A | 2024-11-01 A | 383FS+26d | 100% |  | 2024-11-01 | 2024-11-01 | 0d |  |  |  |  |  |  | PP | SI Test | DBT | 6.0 | Roger Robar | Design, Build & Test (PIT) | Complete | COMPLETE | T3-DB-0155 | SITAG | T3 |  |  |
| 392 | 1.3.6.4.3.7.4.2 | SIT Non-Functional Test scenarios MHHS Review Completed | milestone | 0d | 2024-11-29 | 2024-11-29 | 391FS+20d |  |  | 2024-11-29 | 2024-11-29 | 0d |  |  | 31738d | 15d |  |  | SI Test | PP | DBT | 6.0 | Roger Robar | Design, Build & Test (PIT) | Green | RED | T3-DB-0156 | SITAG | T3 |  | -20.29 |
| 393 | 1.3.6.4.3.7.5 | **PIT execution** |  | 161d | 2024-07-12 A | 2025-02-21 |  | 61% | 63.37d | 2024-07-12 | 2024-12-20 | 301d |  |  | 32307d |  |  | -0 | N/A | N/A | DBT | 6.0 | N/A | Design, Build & Test (PIT) |  |  |  |  |  |  |  |
| 394 | 1.3.6.4.3.7.5.1 | PIT Test Execution Progress Report |  | 50d | 2024-07-15 A | 2024-11-21 | 386 | 56% | 22d | 2024-07-15 | 2024-11-21 | 39d |  |  | 31616d | 6d | finish no earlier than 2024-11-21 |  | PP | SI Test | DBT | 6.0 | Roger Robar | Design, Build & Test (PIT) | Green | RED |  |  |  |  |  |
| 395 | 1.3.6.4.3.7.5.2 | PIT Execution |  | 44d | 2024-07-12 A | 2024-11-29 | 391FS+5d | 66% | 15d | 2024-07-12 | 2024-11-29 | 290d |  |  | 31610d | 0d | finish no earlier than 2024-11-29 |  | PP | SI Test | DBT | 6.0 | Roger Robar | Design, Build & Test (PIT) | Green | RED |  |  |  |  |  |
| 396 | 1.3.6.4.3.7.5.3 | SIT Non-Functional PIT Completion Report submitted to Programme for assurance | milestone | 0d | 2024-11-29 | 2024-11-29 | 394, 395 |  |  | 2024-11-29 | 2024-11-29 | 0d | 2024-01-05 | 2024-01-05 | 31723d | 0d |  |  | PP | SI Test | DBT | 6.0 | Roger Robar | Design, Build & Test (PIT) | Green | RED | T3-DB-0157 | SITAG | T3 |  | -20.29 |
| 397 | 1.3.6.4.3.7.5.4 | SIT Non-Functional PIT Completion Report Theme 1 MHHS Review Completed | milestone | 0d | 2024-12-20 A | 2024-12-20 | 384, 389, 392, 396FS+15d | 50% | 0d | 2024-12-20 | 2024-12-20 | 0d |  |  | 31610d | 0d |  |  | SI Test | PP | DBT | 6.0 | Roger Robar | Design, Build & Test (PIT) | Green | GREEN | T3-DB-0158 | SITAG | T3 |  |  |
| 398 | 1.3.6.4.3.7.5.5 | SIT Non-Functional PIT Completion Report Theme 2 & 3 MHHS Review Completed | milestone | 0d | 2025-02-21 | 2025-02-21 | 384, 389, 392, 396FS+60d |  |  |  |  |  |  |  | 32307d | 20d |  |  | SI Test |  | DBT | 6.13 |  |  | No BL | GREEN | T3-DB-0186 | SITAG | T3 |  | 63.71 |
| 399 | 1.3.6.4.3.8 | **All SIT Programme Participants PIT (SIT Operational)** |  | 131d | 2024-07-12 A | 2025-01-10 |  | 46% | 70.48d | 2024-07-12 | 2024-12-20 | 71d |  |  | 31659d |  |  | -0 | N/A | N/A | DBT | 6.0 | N/A | Design, Build & Test (PIT) |  |  |  |  |  |  |  |
| 400 | 1.3.6.4.3.8.1 | **Test Approach & Plan** |  | 40d | 2024-09-27 A | 2024-11-21 |  |  | 40d | 2024-09-27 | 2024-11-21 | 40d |  |  | 31695d |  |  | -0 | N/A | N/A | DBT | 6.0 | N/A | Design, Build & Test (PIT) |  |  |  |  |  |  |  |
| 401 | 1.3.6.4.3.8.1.1 | SIT Operational PIT Test Approach & Plan (PIT) submitted to Programme for assurance | milestone | 0d | 2024-09-27 A | 2024-09-27 A |  | 100% |  | 2024-09-27 | 2024-09-27 | 0d |  |  |  |  | start no earlier than 2024-09-27 |  | PP | SI Test | DBT | 6.0 | Roger Robar | Design, Build & Test (PIT) | Complete | COMPLETE | T3-DB-0159 | SITAG | T3 |  |  |
| 402 | 1.3.6.4.3.8.1.2 | SIT Operational Test approach and plan MHHS Review Completed | milestone | 0d | 2024-11-21 | 2024-11-21 | 401FS+40d |  |  | 2024-11-21 | 2024-11-21 | 0d |  |  | 31669d | 36d |  |  | SI Test | PP | DBT | 6.0 | Roger Robar | Design, Build & Test (PIT) | Green | RED | T3-DB-0160 | SITAG | T3 |  | -28.29 |
| 403 | 1.3.6.4.3.8.2 | **Test Readiness Report** |  | 13d | 2024-10-04 A | 2024-10-22 |  | 42% | 7.5d | 2024-10-04 | 2024-10-22 | 51d |  |  | 0d |  |  |  | N/A | N/A | DBT | 6.0 | N/A | Design, Build & Test (PIT) |  |  |  |  |  |  |  |
| 404 | 1.3.6.4.3.8.2.1 | Test readiness reporting |  | 13d | 2024-10-04 A | 2024-10-22 | 401FS+10d | 42% | 7.5d | 2024-10-04 | 2024-10-22 | 51d |  |  | 0d |  |  |  | PP | 109 | DBT | 6.0 |  | Design, Build & Test (PIT) | Green | RED |  |  |  |  |  |

Notes:
- 384: 19/12/24 - 18/34 test approach reviews completed. RAG'd red because there are some outstanding comments by the programme on test approaches which have not been addressed by PPs, hence why this activity hasn't been completed yet.
- 389: 19/12/24 -18/34 RTTMs reviews complete. Status red because Programme is still expecting responses to feedback from some PPs on PIT RTTMs and understands some of these will not be recieved by the 29/11/24 deadline.
- 392: 19/12/24 - 18/34 scenarios have been completed.
- 396: 19/12/24 - 31/34 SIT Non-Functional PIT Completion Reports have been submitted to the Programme. Status red because not all PIT Completion Reports will be recieved by the baseline finish.
- 397: 19/12/24 - 1/2 Theme 1 Completion Reports assured by the Programme. Status green because the deadline for assurance is 20/12/24, as agreed at NFTWG.
- 398: 19/12/24 - 9/34 Theme 2 & 3 Completion Reports assured by the Programme. Status green because the deadline for assurance is 21/02/24, as agreed at NFTWG.
- 401: 11/12/24 - 33/34 test approach and plans have been submitted to the Programme, this however is complete because the final PP who have not submitted have a seperate appraoch and plan arragement agreed.
- 402: 19/12/24 - 26/34 reviewed. Status red because not all PIT test approach and plans will be recieved by the baseline finish.

| ID | WBS | Task | Type | Duration | Start | Finish | Predecessors | Complete | Remaining | Baseline start | Baseline finish | Baseline duration | Baseline 1 start | Baseline 1 finish | Total slack | Free slack | Constraint | Baseline cost | Responsible | Involved | Text9 | Update Version | MHHS Resource Name | MHHS Programme Phase | Sched Status | RAG | Milestone ID | Text29 | Tier | Task Status | Artefact ID |
| --- | --- | --- | --- | --- | --- | --- | --- | --- | --- | --- | --- | --- | --- | --- | --- | --- | --- | --- | --- | --- | --- | --- | --- | --- | --- | --- | --- | --- | --- | --- | --- |
| 405 | 1.3.6.4.3.8.3 | **Requirements to test Traceability Matrix (RTTM)** |  | 20d | 2024-11-01 A | 2024-11-29 |  |  | 20d | 2024-11-01 | 2024-11-29 | 30d |  |  | 31689d |  |  | -0 | N/A | N/A | DBT | 6.0 | N/A | Design, Build & Test (PIT) |  |  |  |  |  |  |  |
| 406 | 1.3.6.4.3.8.3.1 | SIT Operational PIT RTTM submitted to Programme for assurance | milestone | 0d | 2024-11-01 A | 2024-11-01 A | 401FS+26d | 100% |  | 2024-11-01 | 2024-11-01 | 0d |  |  |  |  |  |  | PP | SI Test | DBT | 6.0 | Roger Robar | Design, Build & Test (PIT) | Complete | COMPLETE | T3-DB-0161 | SITAG | T3 |  |  |
| 407 | 1.3.6.4.3.8.3.2 | SIT Operational RTTM MHHS Review Completed | milestone | 0d | 2024-11-29 | 2024-11-29 | 406FS+20d |  |  | 2024-11-29 | 2024-11-29 | 0d |  |  | 31663d | 30d |  |  | SI Test | PP | DBT | 6.0 | Roger Robar | Design, Build & Test (PIT) | Green | RED | T3-DB-0162 | SITAG | T3 | -20.29 |  |
| 408 | 1.3.6.4.3.8.4 | **Test Scenarios** |  | 20d | 2024-11-01 A | 2024-11-29 |  |  | 20d | 2024-11-01 | 2024-11-29 | 30d |  |  | 31689d |  |  | -0 | N/A | N/A | DBT | 6.0 | N/A | Design, Build & Test (PIT) |  |  |  |  |  |  |  |
| 409 | 1.3.6.4.3.8.4.1 | SIT Operational PIT test scenarios submitted to Programme for assurance | milestone | 0d | 2024-11-01 A | 2024-11-01 A | 401FS+26d | 100% |  | 2024-11-01 | 2024-11-01 | 0d |  |  |  |  |  |  | PP | SI Test | DBT | 6.0 | Roger Robar | Design, Build & Test (PIT) | Complete | COMPLETE | T3-DB-0163 | SITAG | T3 |  |  |
| 410 | 1.3.6.4.3.8.4.2 | SIT Operational Test scenarios MHHS Review Completed | milestone | 0d | 2024-11-29 | 2024-11-29 | 409FS+20d |  |  | 2024-11-29 | 2024-11-29 | 0d |  |  | 31663d | 30d |  |  | SI Test | PP | DBT | 6.0 | Roger Robar | Design, Build & Test (PIT) | Green | RED | T3-DB-0164 | SITAG | T3 | -20.29 |  |
| 411 | 1.3.6.4.3.8.5 | **PIT execution** |  | 131d | 2024-07-12 A | 2025-01-10 |  | 47% | 69.65d | 2024-07-12 | 2024-12-20 | 51d |  |  | 31659d |  |  | -0 | N/A | N/A | DBT | 6.0 | N/A | Design, Build & Test (PIT) |  |  |  |  |  |  |  |
| 412 | 1.3.6.4.3.8.5.1 | PIT Test Execution Progress Report |  | 40d | 2024-07-15 A | 2024-11-21 | 404 | 45% | 22d | 2024-07-15 | 2024-11-21 | 40d |  |  | 31680d | 21d |  |  | PP | SI Test | DBT | 6.0 | Roger Robar | Design, Build & Test (PIT) | Green | GREEN |  |  |  |  |  |
| 413 | 1.3.6.4.3.8.5.2 | PIT Execution |  | 39d | 2024-07-12 A | 2024-11-29 | 409 | 49% | 20d | 2024-07-12 | 2024-11-29 | 41d |  |  | 31659d | 0d |  |  | PP | SI Test | DBT | 6.0 | Roger Robar | Design, Build & Test (PIT) | Green | GREEN |  |  |  |  |  |
| 414 | 1.3.6.4.3.8.5.3 | SIT Operational PIT Completion Report submitted to Programme for assurance | milestone | 0d | 2024-12-20 | 2024-12-20 | 412, 413FS+15d |  |  | 2024-11-29 | 2024-11-29 | 0d | 2024-01-05 | 2024-01-05 | 31633d | 0d |  |  | PP | SI Test | DBT | 6.0 | Roger Robar | Design, Build & Test (PIT) | Red | RED | T3-DB-0165 | SITAG | T3 | 0.71 |  |
| 415 | 1.3.6.4.3.8.5.4 | SIT Operational PIT Completion Report MHHS Review Completed | milestone | 0d | 2025-01-10 | 2025-01-10 | 402, 407, 410, 414FS+15d |  |  | 2024-12-20 | 2024-12-20 | 0d |  |  | 31633d | 0d |  |  | SI Test | PP | DBT | 6.0 | Roger Robar | Design, Build & Test (PIT) | Red | RED | T3-DB-0166 | SITAG | T3 | 21.71 |  |
| 416 | 1.3.6.4.4 | **All Suppliers DBT CIT (Entering at Interval 5)** |  | 71d | 2023-09-15 A | 2023-12-22 A |  | 100% |  | 2023-09-15 | 2023-12-22 | 300d | 2022-10-31 | 2025-03-14 |  |  |  | -0 | N/A | N/A | DBT | 6.0 | N/A | Design, Build & Test (PIT) |  |  |  |  |  |  |  |
| 417 | 1.3.6.4.4.1 | **Test Approach & Plan** |  | 20d | 2023-09-15 A | 2023-10-12 A |  | 100% |  | 2023-09-15 | 2023-10-12 | 19d | 2022-10-31 | 2023-09-29 |  |  |  | -0 | N/A | N/A | DBT | 6.0 | N/A | Design, Build & Test (PIT) |  |  |  |  |  |  |  |
| 418 | 1.3.6.4.4.1.1 | All SIT Suppliers Test Approach & Plans (PIT) submitted to Programme for assurance | milestone | 0d | 2023-09-15 A | 2023-09-15 A |  | 100% |  | 2023-09-15 | 2023-09-15 | 0d | 2023-09-15 | 2023-09-15 |  |  | start no earlier than 2023-09-15 |  | PP | SI Test | DBT | 6.0 |  | Design, Build & Test (PIT) | Complete | COMPLETE | T3-DB-0046 | SITAG | T3 |  |  |
| 419 | 1.3.6.4.4.1.2 | All SIT Suppliers Test Approach & Plans MHHS Review Completed | milestone | 0d | 2023-10-12 A | 2023-10-12 A | 418FS+20d | 100% |  | 2023-10-12 | 2023-10-12 | 0d | 2023-09-18 | 2023-09-29 |  |  |  |  | SI Test | PP | DBT | 6.0 |  | Design, Build & Test (PIT) | Complete | COMPLETE | T3-DB-0167 | SITAG | T3 |  |  |
| 420 | 1.3.6.4.4.2 | **Test Readiness Report** |  | 11d | 2023-09-29 A | 2023-10-13 A |  | 100% |  | 2023-09-29 | 2023-10-13 | 51d | 2023-09-29 | 2023-12-08 |  |  |  |  | N/A | N/A | DBT | 6.0 | N/A | Design, Build & Test (PIT) |  |  |  |  |  |  |  |
| 421 | 1.3.6.4.4.2.1 | Test readiness reporting |  | 11d | 2023-09-29 A | 2023-10-13 A | 418FS+10d | 100% |  | 2023-09-29 | 2023-10-13 | 51d | 2023-09-29 | 2023-12-08 |  |  |  |  | PP | 109 | DBT | 6.0 |  | Design, Build & Test (PIT) | Complete | COMPLETE |  |  |  |  |  |
| 422 | 1.3.6.4.4.3 | **Requirements to test Traceability Matrix (RTTM)** |  | 20d | 2023-10-06 A | 2023-11-03 A |  | 100% |  | 2023-10-06 | 2023-11-03 | 21d | 2022-10-31 | 2023-10-20 |  |  |  | -0 | N/A | N/A | DBT | 6.0 | N/A | Design, Build & Test (PIT) |  |  |  |  |  |  |  |
| 423 | 1.3.6.4.4.3.1 | All SIT Suppliers RTTMs submitted to Programme for assurance | milestone | 0d | 2023-10-06 A | 2023-10-06 A | 418FS+16d | 100% |  | 2023-10-06 | 2023-10-06 | 1d | 2023-10-06 | 2023-10-06 |  |  |  |  | PP | SI Test | DBT | 6.0 |  | Design, Build & Test (PIT) | Complete | COMPLETE | T3-DB-0064 | SITAG | T3 |  | MHHS-ART009 |
| 424 | 1.3.6.4.4.3.2 | All SIT Suppliers RTTMs MHHS Review Completed | milestone | 0d | 2023-11-03 A | 2023-11-03 A | 423FS+20d | 100% |  | 2023-11-03 | 2023-11-03 | 0d | 2023-10-09 | 2023-10-20 |  |  |  |  | SI Test | PP | DBT | 6.0 |  | Design, Build & Test (PIT) | Complete | COMPLETE | T3-DB-0168 | SITAG | T3 |  |  |
| 425 | 1.3.6.4.4.4 | **Test Scenarios** |  | 20d | 2023-10-05 A | 2023-11-02 A |  | 100% |  | 2023-10-05 | 2023-11-02 | 20d | 2022-10-31 | 2023-10-20 |  |  |  | -0 | N/A | N/A | DBT | 6.0 | N/A | Design, Build & Test (PIT) |  |  |  |  |  |  |  |
| 426 | 1.3.6.4.4.4.1 | All SIT Suppliers test scenarios' submitted to Programme for assurance | milestone | 0d | 2023-10-05 A | 2023-10-05 A | 418FS+15d | 100% |  | 2023-10-05 | 2023-10-05 | 0d | 2023-10-06 | 2023-10-06 |  |  |  |  | PP | SI Test | DBT | 6.0 |  | Design, Build & Test (PIT) | Complete | COMPLETE | T3-DB-0037 | SITAG | T3 |  |  |
| 427 | 1.3.6.4.4.4.2 | All SIT Suppliers Test scenarios' MHHS Review Completed | milestone | 0d | 2023-11-02 A | 2023-11-02 A | 426FS+20d | 100% |  | 2023-11-02 | 2023-11-02 | 0d | 2023-10-09 | 2023-10-20 |  |  |  |  | SI Test | PP | DBT | 6.0 |  | Design, Build & Test (PIT) | Complete | COMPLETE | T3-DB-0169 | SITAG | T3 |  |  |
| 428 | 1.3.6.4.4.5 | **PIT execution** |  | 51d | 2023-10-13 A | 2023-12-22 A |  | 100% |  | 2023-10-13 | 2023-12-22 | 300d | 2022-10-31 | 2023-12-08 |  |  |  | -0 | N/A | N/A | DBT | 6.0 | N/A | Design, Build & Test (PIT) |  |  |  |  |  |  |  |
| 429 | 1.3.6.4.4.5.1 | PIT Test Execution Progress Report |  | 40d | 2023-10-16 A | 2023-12-08 A | 426FS+5d, 421 | 100% |  | 2023-10-16 | 2023-12-08 | 40d | 2022-10-31 | 2023-12-01 |  |  |  |  | PP | SI Test | DBT | 6.0 |  | Design, Build & Test (PIT) | Complete | COMPLETE |  |  |  |  |  |
| 430 | 1.3.6.4.4.5.2 | PIT Execution |  | 41d | 2023-10-13 A | 2023-12-08 A | 426FS+5d | 100% |  | 2023-10-13 | 2023-12-08 | 290d | 2022-10-31 | 2023-12-08 |  |  |  |  | PP | SI Test | DBT | 6.0 |  | Design, Build & Test (PIT) | Complete | COMPLETE |  |  |  |  |  |
| 431 | 1.3.6.4.4.5.3 | All SIT Suppliers PIT Completion Reports submitted to Programme for assurance | milestone | 0d | 2023-12-08 A | 2023-12-08 A | 430, 429 | 100% |  | 2023-12-08 | 2023-12-08 | 0d | 2024-01-05 | 2024-01-05 |  |  |  |  | PP | SI Test | DBT | 6.0 |  | Design, Build & Test (PIT) | Complete | COMPLETE | T3-DB-0170 | SITAG | T3 |  |  |
| 432 | 1.3.6.4.4.5.4 | All SIT Suppliers PIT Completion Reports MHHS Review Completed | milestone | 0d | 2023-12-22 A | 2023-12-22 A | 431FS+10d, 419, 424, 427 | 100% |  | 2023-12-22 | 2023-12-22 | 0d |  |  |  |  |  |  | SI Test | PP | DBT | 6.0 |  | Design, Build & Test (PIT) | Complete | COMPLETE | T3-DB-0171 | SITAG | T3 |  |  |

Notes:
- 406: 19/12/24 - 33/34 SIT Operational PIT RTTMs have been submitted to the Programme, this however is complete because the final PP who have not submitted have a seperate appraoch and plan arragement agreed.
- 407: 19/12/24 - 17/34 reviewed. RAG is red because velocity of RTTM returns by PPs means all reviews won't be completed in time for the baseline finish.
- 409: 19/12/24 - 33/34 SIT Operational PIT test scenarios have been submitted to the Programme, this however is complete because the final PP who have not submitted have a seperate appraoch and plan arragement agreed.
- 410: 19/12/24 - 25/34 reviewed. RAG is red because velocity of test scenario returns by PPs means all reviews won't be completed in time for the baseline finish.
- 414: 19/12/24 - 26/34 submitted. RAG is red because velocity of PIT Completion Report submissions by PPs means all reviews won't be completed in time for the baseline finish.
- 415: 19/12/24 - 0/34 submitted. RAG is Amber because velocity of submissions by PPs means all reviews might not be completed in time for the deadline. Note this date will be revised once a decision on the Settlement testing timelines is agreed.

| ID | WBS | Task | Type | Duration | Start | Finish | Predecessors | Complete | Actual start | Actual finish | Baseline start | Baseline finish | Baseline duration | Baseline 1 start | Baseline 1 finish | Constraint | Baseline cost | Responsible | Involved | Text9 | Update Version | MHHS Resource Name | MHHS Programme Phase | Sched Status | RAG | Milestone ID | Text29 | Tier | Artefact ID |
| --- | --- | --- | --- | --- | --- | --- | --- | --- | --- | --- | --- | --- | --- | --- | --- | --- | --- | --- | --- | --- | --- | --- | --- | --- | --- | --- | --- | --- | --- |
| 433 | 1.3.6.4.5 | **All LDSO Network Operations DBT CIT (Entering at Interval 5)** |  | 71d | 2023-09-15 A | 2023-12-22 A |  | 100% |  |  | 2023-09-15 | 2023-12-22 | 310d | 2022-10-31 | 2025-03-14 |  | -0 | N/A | N/A | DBT | 5.0 | N/A | Design, Build & Test (PIT) |  |  |  |  |  |  |
| 434 | 1.3.6.4.5.1 | **Test Approach & Plan** |  | 71d | 2023-09-15 A | 2023-12-22 A |  | 100% |  |  | 2023-09-15 | 2023-12-22 | 310d | 2022-10-31 | 2023-08-11 |  | -0 | N/A | N/A | DBT | 5.0 | N/A | Design, Build & Test (PIT) |  |  |  |  |  |  |
| 435 | 1.3.6.4.5.1.1 | All Network Operation Test Approach & Plans (PIT) submitted to Programme for assurance | milestone | 0d | 2023-09-15 A | 2023-09-15 A |  | 100% |  |  | 2023-09-15 | 2023-09-15 | 0d | 2023-07-28 | 2023-07-28 | start no earlier than 2023-09-15 |  | PP | SI Test | DBT | 5.8 |  | Design, Build & Test (PIT) | Complete | COMPLETE | T3-DB-0054 | SITAG | T3 |  |
| 436 | 1.3.6.4.5.1.2 | All Network Operation Test Approach & Plans MHHS Review Completed | milestone | 0d | 2023-10-12 A | 2023-10-12 A | 435FS+20d | 100% |  |  | 2023-10-12 | 2023-10-12 | 0d | 2023-07-31 | 2023-08-11 |  |  | SI Test | PP | DBT | 5.8 |  | Design, Build & Test (PIT) | Complete | COMPLETE | T3-DB-0172 | SITAG | T3 |  |
| 437 | 1.3.6.4.5.1.3 | **Test Readiness Report** |  | 11d | 2023-09-29 A | 2023-10-13 A |  | 100% |  |  | 2023-09-29 | 2023-10-13 | 51d | 2023-08-11 | 2023-10-20 |  |  | N/A | N/A | DBT | 5.0 | N/A | Design, Build & Test (PIT) |  |  |  |  |  |  |
| 438 | 1.3.6.4.5.1.3.1 | Test readiness reporting |  | 11d | 2023-09-29 A | 2023-10-13 A | 435FS+10d | 100% |  |  | 2023-09-29 | 2023-10-13 | 51d | 2023-08-11 | 2023-10-20 |  |  | PP | 109 | DBT | 5.0 |  | Design, Build & Test (PIT) | Complete | COMPLETE |  |  |  |  |
| 439 | 1.3.6.4.5.1.4 | **Requirements to test Traceability Matrix (RTTM)** |  | 20d | 2023-10-05 A | 2023-11-02 A |  | 100% |  |  | 2023-10-05 | 2023-11-02 | 20d | 2022-10-31 | 2023-09-15 |  | -0 | N/A | N/A | DBT | 5.0 | N/A | Design, Build & Test (PIT) |  |  |  |  |  |  |
| 440 | 1.3.6.4.5.1.4.1 | All Network Operation RTTMs submitted to Programme for assurance | milestone | 0d | 2023-10-05 A | 2023-10-05 A | 435FS+15d | 100% |  |  | 2023-10-05 | 2023-10-05 | 0d | 2023-09-01 | 2023-09-01 | start no earlier than 2023-04-28 |  | PP | SI Test | DBT | 5.8 |  | Design, Build & Test (PIT) | Complete | COMPLETE | T3-DB-0062 | SITAG | T3 | MHHS-ART009 |
| 441 | 1.3.6.4.5.1.4.2 | All Network Operation RTTMs MHHS Review Completed | milestone | 0d | 2023-11-02 A | 2023-11-02 A | 440FS+20d | 100% |  |  | 2023-11-02 | 2023-11-02 | 0d | 2023-09-04 | 2023-09-15 |  |  | SI Test | PP | DBT | 5.14 |  | Design, Build & Test (PIT) | Complete | COMPLETE | T3-DB-0173 | SITAG | T3 |  |
| 442 | 1.3.6.4.5.1.5 | **Test Scenarios** |  | 20d | 2023-10-05 A | 2023-11-02 A |  | 100% |  |  | 2023-10-05 | 2023-11-02 | 20d | 2022-10-31 | 2023-09-15 |  | -0 | N/A | N/A | DBT | 5.0 | N/A | Design, Build & Test (PIT) |  |  |  |  |  |  |
| 443 | 1.3.6.4.5.1.5.1 | All Network Operation test scenarios' submitted to Programme for assurance | milestone | 0d | 2023-10-05 A | 2023-10-05 A | 435FS+15d | 100% |  |  | 2023-10-05 | 2023-10-05 | 0d | 2023-09-01 | 2023-09-01 |  |  | PP | SI Test | DBT | 5.8 |  | Design, Build & Test (PIT) | Complete | COMPLETE | T3-DB-0011 | SITAG | T3 |  |
| 444 | 1.3.6.4.5.1.5.2 | All Network Operation test scenarios' MHHS Review Completed | milestone | 0d | 2023-11-02 A | 2023-11-02 A | 443FS+20d | 100% |  |  | 2023-11-02 | 2023-11-02 | 0d | 2023-09-04 | 2023-09-15 |  |  | SI Test | PP | DBT | 5.14 |  | Design, Build & Test (PIT) | Complete | COMPLETE | T3-DB-0174 | SITAG | T3 |  |
| 445 | 1.3.6.4.5.1.6 | **PIT execution** |  | 51d | 2023-10-13 A | 2023-12-22 A |  | 100% |  |  | 2023-10-13 | 2023-12-22 | 310d | 2022-10-31 | 2024-01-05 |  | -0 | N/A | N/A | DBT | 5.0 | N/A | Design, Build & Test (PIT) |  |  |  |  |  |  |
| 446 | 1.3.6.4.5.1.6.1 | PIT Test Execution Progress Report |  | 40d | 2023-10-16 A | 2023-12-08 A | 443FS+5d, 438 | 100% |  |  | 2023-10-16 | 2023-12-08 | 305d | 2022-10-31 | 2023-12-29 |  |  | PP | SI Test | DBT | 5.0 |  | Design, Build & Test (PIT) | Complete | COMPLETE |  |  |  |  |
| 447 | 1.3.6.4.5.1.6.2 | PIT Execution |  | 41d | 2023-10-13 A | 2023-12-08 A | 443FS+5d | 100% |  |  | 2023-10-13 | 2023-12-08 | 310d | 2022-10-31 | 2024-01-05 |  |  | PP | SI Test | DBT | 5.0 |  | Design, Build & Test (PIT) | Complete | COMPLETE |  |  |  |  |
| 448 | 1.3.6.4.5.1.6.3 | All Network Operation PIT (CIT interval 5) Completion Reports submitted to Programme for assurance | milestone | 0d | 2023-12-08 A | 2023-12-08 A | 447, 446 | 100% |  |  | 2023-12-08 | 2023-12-08 | 0d | 2024-01-05 | 2024-01-05 |  |  | PP | SI Test | DBT | 5.0 |  | Design, Build & Test (PIT) | Complete | COMPLETE | T3-DB-0175 | SITAG | T3 |  |
| 449 | 1.3.6.4.5.1.6.4 | All Network Operation PIT (CIT interval 5) Completion Reports MHHS Review Completed | milestone | 0d | 2023-12-22 A | 2023-12-22 A | 448FS+10d, 436, 441, 444 | 100% |  |  | 2023-12-22 | 2023-12-22 | 0d |  |  |  |  | SI Test | PP | DBT | 5.15 |  | Design, Build & Test (PIT) | Complete | COMPLETE | T3-DB-0176 | SITAG | T3 |  |
| 450 | 1.3.6.4.6 | **All UMSO DBT CIT (Entering at Interval 6)** |  | 81d | 2023-09-29 | 2024-01-19 A |  | 100% | 2023-10-13 |  | 2023-09-29 | 2024-01-19 | 320d | 2022-10-31 | 2024-05-13 |  | -0 | N/A | N/A | DBT | 5.0 | N/A | Design, Build & Test (PIT) |  |  |  |  |  |  |
| 451 | 1.3.6.4.6.1 | **Test Approach & Plan** |  | 20d | 2023-10-13 A | 2023-11-09 A |  | 100% |  |  | 2023-10-13 | 2023-11-09 | 40d | 2022-10-31 | 2023-09-29 |  | -0 | N/A | N/A | DBT | 5.0 | N/A | Design, Build & Test (PIT) |  |  |  |  |  |  |
| 452 | 1.3.6.4.6.1.1 | All UMSO Test Approach & Plans (PIT) submitted to Programme for assurance | milestone | 0d | 2023-10-13 A | 2023-10-13 A |  | 100% |  |  | 2023-10-13 | 2023-10-13 | 0d | 2023-09-15 | 2023-09-15 | start no earlier than 2023-10-13 |  | PP | SI Test | DBT | 5.11 |  | Design, Build & Test (PIT) | Complete | COMPLETE | T3-DB-0052 | SITAG | T3 |  |
| 453 | 1.3.6.4.6.1.2 | All UMSO Test Approach & Plans MHHS Review Completed | milestone | 0d | 2023-11-09 A | 2023-11-09 A | 452FS+20d | 100% |  |  | 2023-11-09 | 2023-11-09 | 0d | 2023-09-18 | 2023-09-29 |  |  | SI Test | PP | DBT | 5.10 |  | Design, Build & Test (PIT) | Complete | COMPLETE | T3-DB-0177 | SITAG | T3 |  |
| 454 | 1.3.6.4.6.2 | **Test Readiness Report** |  | 11d | 2023-09-29 | 2023-10-13 |  | 100% | 2023-10-27 | 2023-11-10 | 2023-09-29 | 2023-10-13 | 11d | 2023-09-29 | 2023-12-08 |  | -0 | N/A | N/A | DBT | 5.0 | N/A | Design, Build & Test (PIT) |  |  |  |  |  |  |
| 455 | 1.3.6.4.6.2.1 | Test readiness reporting |  | 11d | 2023-10-27 A | 2023-11-10 A | 452FS+10d | 100% |  |  | 2023-10-27 | 2023-11-10 | 11d | 2023-09-29 | 2023-12-08 |  |  | PP | 109 | DBT | 5.0 |  | Design, Build & Test (PIT) | Complete | COMPLETE |  |  |  |  |
| 456 | 1.3.6.4.6.3 | **Requirements to test Traceability Matrix (RTTM)** |  | 20d | 2023-10-05 | 2023-11-01 |  | 100% | 2023-11-02 | 2023-11-30 | 2023-10-05 | 2023-11-01 | 20d | 2022-10-31 | 2023-10-20 |  | -0 | N/A | N/A | DBT | 5.0 | N/A | Design, Build & Test (PIT) |  |  |  |  |  |  |
| 457 | 1.3.6.4.6.3.1 | All UMSO RTTMs submitted to Programme for assurance | milestone | 0d | 2023-11-02 A | 2023-11-02 A | 452FS+15d | 100% |  |  | 2023-11-02 | 2023-11-02 | 0d | 2023-10-06 | 2023-10-06 |  |  | PP | SI Test | DBT | 5.12 |  | Design, Build & Test (PIT) | Complete | COMPLETE | T3-DB-0060 | SITAG | T3 | MHHS-ART009 |
| 458 | 1.3.6.4.6.3.2 | All UMSO RTTMs MHHS Review Completed | milestone | 0d | 2023-11-30 A | 2023-11-30 A | 457FS+20d | 100% |  |  | 2023-11-30 | 2023-11-30 | 0d | 2023-10-09 | 2023-10-20 |  |  | SI Test | PP | DBT | 5.12 |  | Design, Build & Test (PIT) | Complete | COMPLETE | T3-DB-0178 | SITAG | T3 |  |

| ID | WBS | Task | Type | Duration | Start | Finish | Predecessors | Complete | Remaining | Actual start | Actual finish | Baseline start | Baseline finish | Baseline duration | Baseline 1 start | Baseline 1 finish | Total slack | Constraint | Baseline cost | Responsible | Involved | Text9 | Update Version | MHHS Resource Name | MHHS Programme Phase | Sched Status | RAG | Milestone ID | Text29 | Tier | Task Status |
| --- | --- | --- | --- | --- | --- | --- | --- | --- | --- | --- | --- | --- | --- | --- | --- | --- | --- | --- | --- | --- | --- | --- | --- | --- | --- | --- | --- | --- | --- | --- | --- |
| 459 | 1.3.6.4.6.4 | **Test Scenarios** |  | 20d | 2023-10-05 | 2023-11-01 |  | 100% |  | 2023-11-02 | 2023-11-30 | 2023-10-05 | 2023-11-01 | 20d | 2022-10-31 | 2023-10-20 |  |  | -0 | N/A | N/A | DBT | 5.0 | N/A | Design, Build & Test (PIT) |  |  |  |  |  |  |
| 460 | 1.3.6.4.6.4.1 | All UMSO test scenarios' submitted to Programme for assurance | milestone | 0d | 2023-11-02 A | 2023-11-02 A | 452FS+15d | 100% |  |  |  | 2023-11-02 | 2023-11-02 | 0d | 2023-10-06 | 2023-10-06 |  |  |  | PP | SI Test | DBT | 5.12 |  | Design, Build & Test (PIT) | Complete | COMPLETE | T3-DB-0025 | SITAG | T3 |  |
| 461 | 1.3.6.4.6.4.2 | All UMSO Test scenarios' MHHS Review Completed | milestone | 0d | 2023-11-30 A | 2023-11-30 A | 460FS+20d | 100% |  |  |  | 2023-11-30 | 2023-11-30 | 0d | 2023-10-09 | 2023-10-20 |  |  |  | SI Test | PP | DBT | 5.10 |  | Design, Build & Test (PIT) | Complete | COMPLETE | T3-DB-0179 | SITAG | T3 |  |
| 462 | 1.3.6.4.6.5 | **PIT execution** |  | 51d | 2023-11-10 A | 2024-01-19 A |  | 100% |  |  |  | 2023-11-10 | 2024-01-19 | 320d | 2022-10-31 | 2023-12-08 |  |  | -0 | N/A | N/A | DBT | 5.0 | N/A | Design, Build & Test (PIT) |  |  |  |  |  |  |
| 463 | 1.3.6.4.6.5.1 | PIT Test Execution Progress Report |  | 40d | 2023-11-13 A | 2024-01-05 A | 460FS+5d, 455 | 100% |  |  |  | 2023-11-13 | 2024-01-05 | 40d | 2022-10-31 | 2023-12-01 |  |  |  | PP | SI Test | DBT | 5.0 |  | Design, Build & Test (PIT) | Complete | COMPLETE |  |  |  |  |
| 464 | 1.3.6.4.6.5.2 | PIT Execution |  | 40d | 2023-11-10 A | 2024-01-04 A | 460FS+5d | 100% |  |  |  | 2023-11-10 | 2024-01-04 | 290d | 2022-10-31 | 2023-12-08 |  |  |  | PP | SI Test | DBT | 5.0 |  | Design, Build & Test (PIT) | Complete | COMPLETE |  |  |  |  |
| 465 | 1.3.6.4.6.5.3 | All UMSO PIT (CIT interval 6) Completion Reports submitted to Programme for assurance | milestone | 0d | 2024-01-05 A | 2024-01-05 A | 464, 463 | 100% |  |  |  | 2024-01-05 | 2024-01-05 | 0d | 2024-01-05 | 2024-01-05 |  |  |  | PP | SI Test | DBT | 5.10 |  | Design, Build & Test (PIT) | Complete | COMPLETE | T3-DB-0180 | SITAG | T3 |  |
| 466 | 1.3.6.4.6.5.4 | All UMSO PIT (CIT interval 6) Completion Reports MHHS Review Completed | milestone | 0d | 2024-01-19 A | 2024-01-19 A | 453, 458, 461, 465FS+10d | 100% |  |  |  | 2024-01-19 | 2024-01-19 | 0d |  |  |  |  |  | SI Test | PP | DBT | 5.10 |  | Design, Build & Test (PIT) | Complete | COMPLETE | T3-DB-0181 | SITAG | T3 |  |
| 467 | 1.3.7 | **DBT Monitoring and Assurance** |  | 842d | 2022-10-31 A | 2026-01-20 |  | 69% | 262.62d |  |  | 2022-10-31 | 2026-01-20 | 842d | 2022-10-31 | 2026-01-19 | 32075d |  |  | N/A | N/A | DBT | 5.0 | N/A | Design, Build & Test (PIT) |  |  |  |  |  |  |
| 468 | 1.3.7.1 | **Planning and DBT Progress Monitoring of PPs** |  | 696d | 2022-10-31 A | 2025-06-30 |  | 67% | 233d |  |  | 2022-10-31 | 2025-06-30 | 696d | 2022-10-31 | 2025-06-30 | 32221d |  |  | N/A | N/A | DBT | 5.0 | N/A | Design, Build & Test (PIT) |  |  |  |  |  | M9 |
| 469 | 1.3.7.1.1 | Monitor Non-SIT PPs Planning and DBT1 progress (to inform confirmation of Qualification Testing Tranche participants milestones) |  | 696d | 2022-10-31 A | 2025-06-30 | 181SS | 67% | 233d |  |  | 2022-10-31 | 2025-06-30 | 696d | 2022-10-31 | 2025-06-30 | 32221d |  |  | Code Bodies | SI Test,PPC | DBT | 5.0 | Roger Robar | Design, Build & Test (PIT) | Green | GREEN |  |  |  |  |
| 470 | 1.3.7.2 | **DBT Progress Monitoring of Consequential Change** |  | 774d | 2023-02-02 A | 2026-01-20 |  | 51% | 379d |  |  | 2023-02-02 | 2026-01-20 | 774d | 2023-02-01 | 2026-01-19 | 32075d |  |  | N/A | N/A | DBT | 5.0 | N/A | Design, Build & Test (PIT) |  |  |  |  |  | M9 |
| 471 | 1.3.7.2.1 | Monitor & report data cleanse progress |  | 774d | 2023-02-02 A | 2026-01-20 |  | 51% | 379d |  |  | 2023-02-02 | 2026-01-20 | 774d | 2023-02-01 | 2026-01-19 | 32075d |  |  | SI Test | PPC | DBT | 5.0 | Matthew Breen | Design, Build & Test (PIT) | Green | GREEN |  |  |  |  |
| 472 | 1.3.7.3 | **Design Assurance** |  | 713d | 2022-11-14 A | 2025-08-06 |  | 80% | 142.32d |  |  | 2022-11-14 | 2025-08-06 | 713d | 2022-11-14 | 2025-08-06 | 32194d |  |  | N/A | N/A | DBT | 5.0 | N/A | Design, Build & Test (PIT) |  |  |  |  |  | M9 |
| 473 | 1.3.7.3.1 | **Design Assurance Readiness Assessment Preparation** |  | 39d | 2023-02-28 A | 2023-04-21 A |  | 100% |  |  |  | 2023-02-28 | 2023-04-21 | 39d | 2023-02-28 | 2023-04-21 |  |  |  | N/A | N/A | DBT | 5.0 | N/A | Design, Build & Test (PIT) |  |  |  |  |  |  |
| 474 | 1.3.7.3.1.1 | Set up FTIG |  | 15d | 2023-04-03 A | 2023-04-21 A |  | 100% |  |  |  | 2023-04-03 | 2023-04-21 | 15d | 2023-04-03 | 2023-04-21 |  | must start on 2023-04-03 |  | SI Design |  | DBT | 5.0 | Paul Pettitt | Design, Build & Test (PIT) | Complete | COMPLETE |  |  |  |  |
| 475 | 1.3.7.3.1.2 | Produce Draft Questions |  | 10d | 2023-02-28 A | 2023-03-13 A |  | 100% |  |  |  | 2023-02-28 | 2023-03-13 | 10d | 2023-02-28 | 2023-03-13 |  | must start on 2023-02-28 |  | SI Design |  | DBT | 5.0 | Paul Pettitt | Design, Build & Test (PIT) | Complete | COMPLETE |  |  |  |  |
| 476 | 1.3.7.3.1.3 | Pilot with SRO |  | 1d | 2023-03-14 A | 2023-03-14 A | 475 | 100% |  |  |  | 2023-03-14 | 2023-03-14 | 1d | 2023-03-14 | 2023-03-14 |  |  |  | SI Design |  | DBT | 5.0 | Paul Pettitt | Design, Build & Test (PIT) | Complete | COMPLETE |  |  |  |  |
| 477 | 1.3.7.3.1.4 | Finalise questions |  | 10d | 2023-03-15 A | 2023-03-28 A | 476 | 100% |  |  |  | 2023-03-15 | 2023-03-28 | 10d | 2023-03-15 | 2023-03-28 |  |  |  | SI Design |  | DBT | 5.0 | Paul Pettitt | Design, Build & Test (PIT) | Complete | COMPLETE |  |  |  |  |
| 478 | 1.3.7.3.1.5 | Prepare on-line RA tooling |  | 10d | 2023-03-29 A | 2023-04-11 A | 477 | 100% |  |  |  | 2023-03-29 | 2023-04-11 | 10d | 2023-03-29 | 2023-04-11 |  |  |  | SI Design |  | DBT | 5.0 | Paul Pettitt | Design, Build & Test (PIT) | Complete | COMPLETE |  |  |  |  |
| 479 | 1.3.7.3.1.6 | Prepare webinar content |  | 5d | 2023-03-20 A | 2023-03-24 A | 475FS+4d | 100% |  |  |  | 2023-03-20 | 2023-03-24 | 5d | 2023-03-20 | 2023-03-24 |  |  |  | SI Design |  | DBT | 5.0 | Paul Pettitt | Design, Build & Test (PIT) | Complete | COMPLETE |  |  |  |  |
| 480 | 1.3.7.3.1.7 | Conduct webinar |  | 1d | 2023-03-30 A | 2023-03-30 A | 479FS+3d | 100% |  |  |  | 2023-03-30 | 2023-03-30 | 1d | 2023-03-30 | 2023-03-30 |  |  |  | SI Design | PP | DBT | 5.0 | Paul Pettitt | Design, Build & Test (PIT) | Complete | COMPLETE |  |  |  |  |
| 481 | 1.3.7.3.2 | **Participant Design Assurance Approach** |  | 43d | 2022-11-14 A | 2023-01-11 A |  | 100% |  |  |  | 2022-11-14 | 2023-01-11 | 43d | 2022-11-14 | 2023-01-11 |  |  |  | N/A | N/A | DBT | 5.0 | N/A | Design, Build & Test (PIT) |  |  |  |  |  |  |
| 482 | 1.3.7.3.2.1 | Develop document |  | 20d | 2022-11-14 A | 2022-12-09 A | 47FS+10d | 100% |  |  |  | 2022-11-14 | 2022-12-09 | 20d | 2022-11-14 | 2022-12-09 |  | start no earlier than 2022-11-14 |  | SI Design | PP | DBT | 5.0 | Paul Pettitt | Design, Build & Test (PIT) | Complete | COMPLETE |  |  |  |  |
| 483 | 1.3.7.3.2.2 | Review document |  | 18d | 2022-12-12 A | 2023-01-04 A | 482 | 100% |  |  |  | 2022-12-12 | 2023-01-04 | 18d | 2022-12-12 | 2023-01-04 |  |  |  | PP | SI Design,IPA | DBT | 5.0 | Paul Pettitt | Design, Build & Test (PIT) | Complete | COMPLETE |  |  |  |  |
| 484 | 1.3.7.3.2.3 | Participant Design Assurance Approach approved | milestone | 0d | 2023-01-11 A | 2023-01-11 A | 483FF+5d | 100% |  |  |  | 2023-01-11 | 2023-01-11 | 0d | 2023-01-11 | 2023-01-11 |  |  |  | SI Design | PP | DBT | 5.0 | Paul Pettitt | Design, Build & Test (PIT) | Complete | COMPLETE | T3-DB-0012 | DAG | T3 |  |

| ID | WBS | Task | Type | Duration | Start | Finish | Predecessors | Complete | Remaining | Baseline start | Baseline finish | Baseline duration | Baseline 1 start | Baseline 1 finish | Total slack | Constraint | Responsible | Involved | Text9 | Update Version | MHHS Resource Name | MHHS Programme Phase | Sched Status | RAG | Artefact ID | Milestone ID | Text29 | Tier | Task Status |
| --- | --- | --- | --- | --- | --- | --- | --- | --- | --- | --- | --- | --- | --- | --- | --- | --- | --- | --- | --- | --- | --- | --- | --- | --- | --- | --- | --- | --- | --- |
| 485 | 1.3.7.3.3 | **Phase 1 - SIT Volunteers (Core Providers)** |  | 145d | 2023-04-10 A | 2023-10-27 A |  | 100% |  | 2023-04-10 | 2023-10-27 | 145d | 2023-04-10 | 2023-10-27 |  |  | N/A | N/A | DBT | 5.0 | N/A | Design, Build & Test (PIT) |  |  |  |  |  |  |  |
| 486 | 1.3.7.3.3.1 | Send on-line questionnaire to core capability providers and current SIT volunteers (from Round 3 consultation) |  | 1d | 2023-04-10 A | 2023-04-10 A |  | 100% |  | 2023-04-10 | 2023-04-10 | 1d | 2023-04-10 | 2023-04-10 |  | must start on 2023-04-10 | SI Design | PP | DBT | 5.0 | Paul Pettitt | Design, Build & Test (PIT) | Complete | COMPLETE |  |  |  |  |  |
| 487 | 1.3.7.3.3.2 | Participants Provide Responses to questionnaires |  | 15d | 2023-04-11 A | 2023-05-01 A | 486 | 100% |  | 2023-04-11 | 2023-05-01 | 15d | 2023-04-11 | 2023-05-01 |  |  | PP |  | DBT | 5.0 | Paul Pettitt | Design, Build & Test (PIT) | Complete | COMPLETE |  |  |  |  |  |
| 488 | 1.3.7.3.3.3 | Assess on-line responses and provided evidence |  | 5d | 2023-05-02 A | 2023-05-08 A | 487 | 100% |  | 2023-05-02 | 2023-05-08 | 5d | 2023-05-02 | 2023-05-08 |  |  | SI Design |  | DBT | 5.0 | Paul Pettitt | Design, Build & Test (PIT) | Complete | COMPLETE |  |  |  |  |  |
| 489 | 1.3.7.3.3.4 | Bi-lateral meeting with each responder, to walk and navigate through provided materials |  | 31d | 2023-05-09 A | 2023-06-20 A | 488 | 100% |  | 2023-05-09 | 2023-06-20 | 31d | 2023-05-09 | 2023-06-20 |  |  | SI Design | PP | DBT | 5.0 | Paul Pettitt | Design, Build & Test (PIT) | Complete | COMPLETE |  |  |  |  |  |
| 490 | 1.3.7.3.3.5 | Plan for, create and execute deep dive assurance interviews based on agreed priorities (participants, design areas) |  | 62d | 2023-06-07 A | 2023-08-31 A | 489FS-10d | 100% |  | 2023-06-07 | 2023-08-31 | 62d | 2023-06-07 | 2023-08-01 |  |  | SI Design |  | DBT | 5.2 | Paul Pettitt | Design, Build & Test (PIT) | Complete | COMPLETE |  |  |  |  |  |
| 491 | 1.3.7.3.3.6 | SI endorsement of participants’ design – assurance reports |  | 43d | 2023-08-02 A | 2023-09-29 A | 490FS-22d | 100% |  | 2023-08-02 | 2023-09-29 | 43d | 2023-08-02 | 2023-08-15 |  |  | SI Design |  | DBT | 5.2 | Paul Pettitt | Design, Build & Test (PIT) | Complete | COMPLETE |  |  |  |  |  |
| 492 | 1.3.7.3.3.7 | Post-assurance review of recommendations take-up by assured participants |  | 44d | 2023-08-29 A | 2023-10-27 A | 491SS+19d | 100% |  | 2023-08-29 | 2023-10-27 | 20d | 2023-08-16 | 2023-10-27 |  |  | SI Design |  | DBT | 5.2 | Paul Pettitt | Design, Build & Test (PIT) | Complete | COMPLETE |  |  |  |  |  |
| 493 | 1.3.7.3.3.8 | Phase 1 - SIT Volunteers (Core Providers) complete | milestone | 0d | 2023-10-27 A | 2023-10-27 A | 492 | 100% |  | 2023-10-27 | 2023-10-27 | 0d | 2023-10-27 | 2023-10-27 |  |  | SI Design |  | DBT | 5.11 | Paul Pettitt | Design, Build & Test (PIT) | Complete | COMPLETE | MHHS-ART002 | T2-DB-0100 | DAG | T2 |  |
| 494 | 1.3.7.3.4 | **Phase 2 - SIT all other participants** |  | 143d | 2023-05-08 A | 2023-11-22 A |  | 100% |  | 2023-05-08 | 2023-11-22 | 143d | 2023-05-08 | 2023-11-22 |  |  | N/A | N/A | DBT | 5.0 | N/A | Design, Build & Test (PIT) |  |  |  |  |  |  |  |
| 495 | 1.3.7.3.4.1 | Send on-line questionnaire to core capability providers and current SIT volunteers (from Round 3 consultation) |  | 1d | 2023-05-08 A | 2023-05-08 A |  | 100% |  | 2023-05-08 | 2023-05-08 | 1d | 2023-05-08 | 2023-05-08 |  | must start on 2023-05-08 | SI Design | PP | DBT | 5.0 | Paul Pettitt | Design, Build & Test (PIT) | Complete | COMPLETE |  |  |  |  |  |
| 496 | 1.3.7.3.4.2 | Participants Provide Responses to questionnaires |  | 15d | 2023-05-09 A | 2023-05-29 A | 495 | 100% |  | 2023-05-09 | 2023-05-29 | 15d | 2023-05-09 | 2023-05-29 |  |  | PP |  | DBT | 5.0 | Paul Pettitt | Design, Build & Test (PIT) | Complete | COMPLETE |  |  |  |  |  |
| 497 | 1.3.7.3.4.3 | Assess on-line responses and provided evidence |  | 5d | 2023-05-30 A | 2023-06-05 A | 496 | 100% |  | 2023-05-30 | 2023-06-05 | 5d | 2023-05-30 | 2023-06-05 |  |  | SI Design |  | DBT | 5.0 | Paul Pettitt | Design, Build & Test (PIT) | Complete | COMPLETE |  |  |  |  |  |
| 498 | 1.3.7.3.4.4 | Bi-lateral meeting with each responder, to walk and navigate through provided materials |  | 84d | 2023-06-06 A | 2023-09-29 A | 497 | 100% |  | 2023-06-06 | 2023-09-29 | 84d | 2023-06-06 | 2023-07-18 |  |  | SI Design | PP | DBT | 5.2 | Paul Pettitt | Design, Build & Test (PIT) | Complete | COMPLETE |  |  |  |  |  |
| 499 | 1.3.7.3.4.5 | Plan for, create and execute deep dive assurance interviews based on agreed priorities (participants, design areas) |  | 69d | 2023-06-27 A | 2023-09-29 A | 498SS+15d | 100% |  | 2023-06-27 | 2023-09-29 | 69d | 2023-07-05 | 2023-08-29 |  |  | SI Design |  | DBT | 5.2 | Paul Pettitt | Design, Build & Test (PIT) | Complete | COMPLETE |  |  |  |  |  |
| 500 | 1.3.7.3.4.6 | SI endorsement of participants’ design – assurance reports |  | 54d | 2023-07-18 A | 2023-09-29 A | 499SS+15d | 100% |  | 2023-07-18 | 2023-09-29 | 54d | 2023-08-30 | 2023-09-12 |  |  | SI Design |  | DBT | 5.2 | Paul Pettitt | Design, Build & Test (PIT) | Complete | COMPLETE |  |  |  |  |  |
| 501 | 1.3.7.3.4.7 | Post-assurance review of recommendations take-up by assured participants |  | 73d | 2023-08-14 A | 2023-11-22 A | 500SS+19d | 100% |  | 2023-08-14 | 2023-11-22 | 38d | 2023-09-13 | 2023-11-22 |  |  | SI Design |  | DBT | 5.2 | Paul Pettitt | Design, Build & Test (PIT) | Complete | COMPLETE |  |  |  |  |  |
| 502 | 1.3.7.3.4.8 | SIT PPs design assurance (excl Migration/Reverse Migration) complete | milestone | 0d | 2023-11-22 A | 2023-11-22 A | 501 | 100% |  | 2023-11-22 | 2023-11-22 | 0d | 2023-11-22 | 2023-11-22 |  |  | SI Design |  | DBT | 5.11 | Paul Pettitt | Design, Build & Test (PIT) | Complete | COMPLETE | MHHS-ART002 | T2-DB-0200 | DAG | T2 |  |
| 503 | 1.3.7.3.5 | **Non-SIT PPs design assurance** |  | 445d | 2023-11-23 A | 2025-08-06 |  | 53% | 207d | 2023-11-23 | 2025-08-06 | 445d | 2023-11-23 | 2025-08-06 | 32194d |  | N/A | N/A | DBT | 5.0 | N/A | Design, Build & Test (PIT) |  |  |  |  |  |  |  |
| 504 | 1.3.7.3.5.1 | Non-SIT PPs design assurance (risk-based sample) |  | 445d | 2023-11-23 A | 2025-08-06 | 502 | 53% | 207d | 2023-11-23 | 2025-08-06 | 445d | 2023-11-23 | 2025-08-06 | 32194d |  | SI Design | PPC | DBT | 5.0 | Paul Pettitt | Design, Build & Test (PIT) | Green | GREEN |  |  |  |  |  |
| 505 | 1.3.7.4 | **Test Assurance** |  | 629d | 2023-02-01 A | 2025-06-30 |  | 71% | 180d | 2023-02-01 | 2025-06-30 | 696d | 2022-10-31 | 2025-06-30 | 32221d |  | N/A | N/A | DBT | 5.0 | N/A | Design, Build & Test (PIT) |  |  |  |  |  |  | M9 |
| 506 | 1.3.7.4.1 | Non-SIT PPs test assurance |  | 629d | 2023-02-01 A | 2025-06-30 |  | 71% | 180d | 2023-02-01 | 2025-06-30 | 629d | 2023-02-01 | 2025-06-30 | 32221d |  | Code Bodies | PP,PPC,SI Test | DBT | 5.0 | Roger Robar | Design, Build & Test (PIT) | Green | GREEN |  |  |  |  |  |
| 507 | 1.3.7.5 | **Pre-Qualification Guidance (PIT Guidance)** |  | 67d | 2022-10-31 A | 2023-01-31 A |  | 100% |  | 2022-10-31 | 2023-01-31 | 67d | 2022-10-31 | 2023-01-31 |  |  | N/A | N/A | DBT | 5.0 | N/A | Design, Build & Test (PIT) |  |  |  |  |  |  |  |
| 508 | 1.3.7.5.1 | Develop document (incl. collaboration with code bodies, as required) |  | 56d | 2022-10-31 A | 2023-01-16 A |  | 100% |  | 2022-10-31 | 2023-01-16 | 56d | 2022-10-31 | 2023-01-16 |  |  | SI Test | Code Bodies | DBT | 5.0 |  | Design, Build & Test (PIT) | Complete | COMPLETE |  |  |  |  |  |
| 509 | 1.3.7.5.2 | Review, update and agree Pre-Qualification Guidance internally |  | 11d | 2023-01-17 A | 2023-01-31 A | 508 | 100% |  | 2023-01-17 | 2023-01-31 | 11d | 2023-01-17 | 2023-01-31 |  |  | SRO Function | IPA,SI Test | DBT | 5.0 |  | Design, Build & Test (PIT) | Complete | COMPLETE |  |  |  |  |  |

| ID | WBS | Task | Type | Duration | Start | Finish | Predecessors | Complete | Remaining | Baseline start | Baseline finish | Baseline duration | Baseline 1 start | Baseline 1 finish | Total slack | Constraint | Baseline cost | Responsible | Involved | Text9 | Update Version | MHHS Resource Name | MHHS Programme Phase | Sched Status | RAG | Future RAG | Text29 | Task Status | Artefact ID | Milestone ID | Tier |
| --- | --- | --- | --- | --- | --- | --- | --- | --- | --- | --- | --- | --- | --- | --- | --- | --- | --- | --- | --- | --- | --- | --- | --- | --- | --- | --- | --- | --- | --- | --- | --- |
| 510 | 1.3.7.6 | **External Programme Dependency Management** |  | 0d | 2022-11-03 A | 2022-11-03 A |  | 100% |  | 2022-11-03 | 2022-11-03 | 0d | 2022-11-03 | 2022-11-03 |  |  |  | N/A | N/A | DBT | 5.0 | N/A | Design, Build & Test (PIT) |  |  |  |  |  |  |  |  |
| 511 | 1.3.7.6.1 | **SLC47** |  | 0d | 2022-11-03 A | 2022-11-03 A |  | 100% |  | 2022-11-03 | 2022-11-03 | 0d | 2022-11-03 | 2022-11-03 |  |  |  | N/A | N/A | DBT | 5.0 | N/A | Design, Build & Test (PIT) |  |  |  |  |  |  |  |  |
| 512 | 1.3.7.6.1.1 | SLC47 implementation date | milestone | 0d | 2022-11-03 A | 2022-11-03 A |  | 100% |  | 2022-11-03 | 2022-11-03 | 0d | 2022-11-03 | 2022-11-03 |  | start no earlier than 2022-11-03 |  | Ofgem |  | DBT | 5.0 |  | Design, Build & Test (PIT) | Complete | COMPLETE |  |  |  |  |  |  |
| 513 | 1.4 | **SYSTEMS INTEGRATION TESTING (SIT)** |  | 910d? | 2022-10-31 A | 2026-04-24 |  | 62% | 344.82d? | 2022-10-31 | 2026-04-24 | 841d | 2022-10-31 | 2026-01-19 |  |  | -0 | N/A | N/A | SIT |  | N/A | Systems Integration Testing (SIT) |  |  | 1 Aug 2023 - 30 Sep 2024 | SITAG |  |  |  |  |
| 514 | 1.4.1 | **SIT Preparation** |  | 665d? | 2022-10-31 A | 2025-05-16 |  | 88% | 82.82d? | 2022-10-31 | 2025-05-16 | 611d | 2022-10-31 | 2025-03-10 | 32252d |  | -0 | N/A | N/A | SIT | 5.0 | N/A | Systems Integration Testing (SIT) |  |  |  | SITAG |  |  |  |  |
| 515 | 1.4.1.1 | **Test Artefact Development** |  | 472d | 2022-10-31 A | 2024-08-21 |  | 99% | 2.69d | 2022-10-31 | 2024-08-21 | 472d | 2022-10-31 | 2023-09-01 | 32445d |  | -0 | N/A | N/A | SIT | 5.0 | N/A | Systems Integration Testing (SIT) |  |  |  |  | M9 |  |  |  |
| 516 | 1.4.1.1.1 | **Environment Approach & Plan** |  | 460d | 2022-11-16 A | 2024-08-21 A |  | 100% |  | 2022-11-16 | 2024-08-21 | 460d | 2022-11-16 | 2023-06-30 |  |  | -0 | N/A | N/A | SIT | 5.0 | N/A | Systems Integration Testing (SIT) |  |  |  |  |  |  |  |  |
| 517 | 1.4.1.1.1.1 | Environment Approach & Plan approved | milestone | 0d | 2022-11-16 A | 2022-11-16 A |  | 100% |  | 2022-11-16 | 2022-11-16 | 0d | 2022-11-16 | 2022-11-16 |  | start no earlier than 2022-11-16 |  | SI Test | PP | SIT | 5.0 | Simon Berry | Systems Integration Testing (SIT) | Complete | COMPLETE |  | SITAG |  | MHHS-ART139 | T3-TE-0010 | T3 |
| 518 | 1.4.1.1.1.2 | Environment Approach & Plan - Work Off |  | 157d | 2022-11-17 A | 2023-06-23 A | 517FS+1d | 100% |  | 2022-11-17 | 2023-06-23 | 157d | 2022-11-17 | 2023-06-23 |  |  |  | SI Test | PP | SIT | 5.0 | Simon Berry | Systems Integration Testing (SIT) | Complete | COMPLETE |  |  |  |  |  |  |
| 519 | 1.4.1.1.1.3 | Environment Approach & Plan - Work Off Approved | milestone | 0d | 2023-08-16 A | 2023-08-16 A | 518FS+5d | 100% |  | 2023-08-16 | 2023-08-16 | 0d | 2023-06-30 | 2023-06-30 |  | start no earlier than 2023-08-16 |  | SI Test | PP | SIT | 5.0 | Simon Berry | Systems Integration Testing (SIT) | Complete | COMPLETE |  | SITAG |  | MHHS-ART139 | T3-TE-0068 | T3 |
| 520 | 1.4.1.1.1.4 | Environment Approach and Plan - SIT Functional | milestone | 0d | 2023-11-20 A | 2023-11-20 A |  | 100% |  | 2023-11-20 | 2023-11-20 | 0d |  |  |  | start no earlier than 2023-11-20 |  | SI Test | PP | SIT | 5.12 | Simon Berry | Systems Integration Testing (SIT) | Complete | COMPLETE |  | SITAG |  | MHHS-DEL 618 | T3-TE-0090 | T3 |
| 521 | 1.4.1.1.1.5 | Define Approach to Simulator for Non-SIT LDSO | milestone | 0d | 2023-11-15 A | 2023-11-15 A |  | 100% |  | 2023-11-15 | 2023-11-15 | 0d |  |  |  | start no earlier than 2023-11-15 |  | SI Test | PP | SIT | 5.12 | Simon Berry |  | Complete | COMPLETE |  |  |  |  |  |  |
| 522 | 1.4.1.1.1.6 | Environment Approach and Plan - Non SIT LDSO Testing | milestone | 0d | 2024-04-17 A | 2024-04-17 A |  | 100% |  | 2024-04-17 | 2024-04-17 | 0d |  |  |  | start no earlier than 2024-04-17 |  | SI Test | PP | SIT | 5.22 | Simon Berry | Systems Integration Testing (SIT) | Complete | COMPLETE |  | SITAG/QAG |  | MHHS-DEL 619 | T3-TE-0091 | T3 |
| 523 | 1.4.1.1.1.7 | Environment Approach and Plan - S and A Testing | milestone | 0d | 2024-07-17 A | 2024-07-17 A |  | 100% |  | 2024-07-17 | 2024-07-17 | 0d |  |  |  | start no earlier than 2024-07-17 |  | SI Test | PP | SIT | 5.27 | Simon Berry | Systems Integration Testing (SIT) | Complete | COMPLETE |  | SITAG/QAG |  | MHHS-DEL 619 | T3-TE-0120 | T3 |
| 524 | 1.4.1.1.1.8 | Environment Approach and Plan - SIT Non Functional | milestone | 0d | 2024-06-19 A | 2024-06-19 A |  | 100% |  | 2024-06-19 | 2024-06-19 | 0d |  |  |  | start no earlier than 2024-06-19 |  | SI Test | PP | SIT | 5.27 | Simon Berry | Systems Integration Testing (SIT) | Complete | COMPLETE |  | SITAG |  | MHHS-DEL 620 | T3-TE-0092 | T3 |
| 525 | 1.4.1.1.1.9 | Environment Approach and Plan - Sandbox | milestone | 0d | 2024-08-21 A | 2024-08-21 A |  | 100% |  | 2024-08-21 | 2024-08-21 | 0d |  |  |  | start no earlier than 2024-08-21 |  | SI Test | PP | SIT | 5.27 | Simon Berry | Systems Integration Testing (SIT) | Complete | COMPLETE |  | SITAG/QAG |  | MHHS-DEL 621 | T3-TE-0093 | T3 |
| 526 | 1.4.1.1.2 | **Overarching Test Scope (for all stages)** |  | 65d | 2022-10-31 A | 2023-01-27 A |  | 100% |  | 2022-10-31 | 2023-01-27 | 175d | 2022-10-31 | 2023-06-30 |  |  |  | N/A | N/A | SIT | 5.0 | N/A | Systems Integration Testing (SIT) |  |  |  |  |  |  |  |  |
| 527 | 1.4.1.1.2.1 | **Overarching Test Scope (excl. Migration/Reverse Migration, NFT and Ops components)** |  | 65d | 2022-10-31 A | 2023-01-27 A |  | 100% |  | 2022-10-31 | 2023-01-27 | 65d | 2022-10-31 | 2023-01-27 |  |  |  | N/A | N/A | SIT | 5.0 | N/A | Systems Integration Testing (SIT) |  |  |  |  |  |  |  |  |
| 528 | 1.4.1.1.2.1.1 | Develop document (excl Migration/Reverse Migration, NFT and Ops components) |  | 55d | 2022-10-31 A | 2023-01-13 A | 47 | 100% |  | 2022-10-31 | 2023-01-13 | 55d | 2022-10-31 | 2023-01-13 |  |  |  | SI Test |  | SIT | 5.0 |  | Systems Integration Testing (SIT) | Complete | COMPLETE |  |  |  |  |  |  |
| 529 | 1.4.1.1.2.1.2 | Review, update & agree document (excl Migration/Reverse Migration, NFT and Ops components) |  | 10d | 2023-01-16 A | 2023-01-27 A | 528 | 100% |  | 2023-01-16 | 2023-01-27 | 10d | 2023-01-16 | 2023-01-27 |  |  |  | SI Test | IPA,Code Bodies,PP | SIT | 5.0 |  | Systems Integration Testing (SIT) | Complete | COMPLETE |  |  |  |  |  |  |
| 530 | 1.4.1.1.3 | **Configuration and Release Management Approach & Plan** |  | 164d | 2022-11-01 A | 2023-06-16 A |  | 100% |  | 2022-11-01 | 2023-06-16 | 164d | 2022-11-01 | 2023-04-28 |  |  |  | N/A | N/A | SIT | 5.0 | N/A | Systems Integration Testing (SIT) |  |  |  |  | M9 |  |  |  |
| 531 | 1.4.1.1.3.1 | Develop document |  | 69d | 2022-11-01 A | 2023-06-16 A |  | 100% |  | 2022-11-01 | 2023-06-16 | 69d | 2022-11-01 | 2023-01-31 |  | start no earlier than 2022-11-01 |  | SI Test |  | SIT | 5.0 | Simon Berry | Systems Integration Testing (SIT) | Complete | COMPLETE |  |  |  |  |  |  |
| 532 | 1.4.1.1.3.2 | Review, update and agree Configuration and Release Management Approach & Plan internally |  | 63d | 2023-02-01 A | 2023-04-28 A | 531 | 100% |  | 2023-02-01 | 2023-04-28 | 63d | 2023-02-01 | 2023-04-28 |  |  |  | SRO Function | IPA,SI Test | SIT | 5.0 | Simon Berry | Systems Integration Testing (SIT) | Complete | COMPLETE |  |  |  |  |  |  |
| 533 | 1.4.1.1.4 | **Test Data Overarching Approach & Plan** |  | 179d | 2022-11-14 A | 2023-07-20 A |  | 100% |  | 2022-11-14 | 2023-07-20 | 179d | 2022-11-14 | 2023-05-18 |  |  |  | N/A | N/A | SIT | 5.0 | N/A | Systems Integration Testing (SIT) |  |  |  |  | M9 |  |  |  |
| 534 | 1.4.1.1.4.1 | Develop document |  | 20d | 2022-11-14 A | 2022-12-09 A |  | 100% |  | 2022-11-14 | 2022-12-09 | 20d | 2022-11-14 | 2022-12-09 |  | start no earlier than 2022-11-14 |  | SI Test | PP | SIT | 5.0 | Cesar Lopes | Systems Integration Testing (SIT) | Complete | COMPLETE |  |  |  |  |  |  |
| 535 | 1.4.1.1.4.2 | Document review and update |  | 155d | 2022-12-12 A | 2023-07-14 A | 534 | 100% |  | 2022-12-12 | 2023-07-14 | 155d | 2022-12-12 | 2023-05-17 |  |  |  | PP | SI Test,IPA | SIT | 5.0 | Cesar Lopes | Systems Integration Testing (SIT) | Complete | COMPLETE |  |  |  |  |  |  |
| 536 | 1.4.1.1.4.3 | Test Data Overarching Approach & Plan approved by TMAG | milestone | 0d | 2023-07-19 A | 2023-07-19 A | 535FS+3d | 100% |  | 2023-07-19 | 2023-07-19 | 0d | 2023-05-17 | 2023-05-17 |  |  |  | SRO Test | PP,IPA,Code Bodies | SIT | 5.0 | Cesar Lopes | Systems Integration Testing (SIT) | Complete | COMPLETE |  | SITAG |  |  | T3-TE-0072 | T3 |
| 537 | 1.4.1.1.4.4 | Document publication final version |  | 1d | 2023-07-20 A | 2023-07-20 A | 536 | 100% |  | 2023-07-20 | 2023-07-20 | 1d | 2023-05-18 | 2023-05-18 |  |  |  | SI Test |  | SIT | 5.0 | Cesar Lopes | Systems Integration Testing (SIT) | Complete | COMPLETE |  |  |  |  |  |  |

Notes:
- 514: Action: 11/3: Ask Simon B for the link (line 1312) dip onboarding to non sit ldso
- 516: Action: 16/8 - add to milestone register. Build out detail further
- 517: Action: 25/7 - Simon to provide update
- 518: Action: 25/7 - Simon to provide update
- 519: Action: 25/7 - Simon to provide update
- 520: Action: 16/8 - add to milestone register. Build out detail further
- 522: Action: 16/8 - add to milestone register. Build out detail further
- 523: Action: 16/8 - add to milestone register. Build out detail further
- 524: Action: 16/8 - add to milestone register. Build out detail further
- 525: Action: 16/8 - add to milestone register. Build out detail further
- 530: Action: 1280 DIP available for Onboarding (need to add a link - non sit ldso)

| ID | WBS | Task | Type | Duration | Start | Finish | Predecessors | Complete | Remaining | Baseline start | Baseline finish | Baseline duration | Baseline 1 start | Baseline 1 finish | Total slack | Constraint | Baseline cost | Responsible | Involved | Text9 | Update Version | MHHS Resource Name | MHHS Programme Phase | Sched Status | RAG | Task Status |
| --- | --- | --- | --- | --- | --- | --- | --- | --- | --- | --- | --- | --- | --- | --- | --- | --- | --- | --- | --- | --- | --- | --- | --- | --- | --- | --- |
| 538 | 1.4.1.1.5 | **Interface Code of Connection (dates subject to DIP Service Provider's plan)** |  | 48d | 2023-03-01 A | 2023-05-05 A |  | 100% |  | 2023-03-01 | 2023-05-05 | 48d | 2023-03-01 | 2023-05-05 |  |  |  | N/A | N/A | SIT | 5.0 | N/A | Systems Integration Testing (SIT) |  |  |  |
| 539 | 1.4.1.1.5.1 | Develop Interface Code of Connection with DIP Service Provider |  | 43d | 2023-03-01 A | 2023-04-28 A |  | 100% |  | 2023-03-01 | 2023-04-28 | 43d | 2023-03-01 | 2023-04-28 |  | must start on 2023-03-01 |  | DIP Provider | SI Test | SIT | 5.0 |  | Systems Integration Testing (SIT) | Complete | COMPLETE |  |
| 540 | 1.4.1.1.5.2 | Interface Code of Connection approved at SDWG | milestone | 0d | 2023-05-05 A | 2023-05-05 A | 539FS+5d | 100% |  | 2023-05-05 | 2023-05-05 | 0d | 2023-05-05 | 2023-05-05 |  |  |  | SI Test | PP | SIT | 5.0 |  | Systems Integration Testing (SIT) | Complete | COMPLETE |  |
| 541 | 1.4.1.1.6 | **Test Traceability** |  | 165d | 2023-06-01 A | 2024-01-17 |  | 98% | 2.71d | 2023-06-01 | 2024-01-17 | 165d | 2023-06-01 | 2023-09-01 | 32599d |  | -0 | N/A | N/A | SIT | 5.0 | N/A | Systems Integration Testing (SIT) |  |  |  |
| 542 | 1.4.1.1.6.1 | RTM containing Method Statement Implied Requirements into Azure DevOps |  | 22d | 2023-06-01 A | 2023-06-30 A |  | 100% |  | 2023-06-01 | 2023-06-30 | 22d | 2023-06-01 | 2023-06-30 |  | must start on 2023-06-01 |  | SI Test |  | SIT | 5.0 |  | Systems Integration Testing (SIT) | Complete | COMPLETE |  |
| 543 | 1.4.1.1.6.2 | RTM Containing Interface Catalogue Implied Requirements |  | 27d | 2023-06-01 A | 2023-07-07 A |  | 100% |  | 2023-06-01 | 2023-07-07 | 27d | 2023-06-01 | 2023-07-07 |  | must start on 2023-06-01 |  | SI Test |  | SIT | 5.0 |  | Systems Integration Testing (SIT) | Complete | COMPLETE |  |
| 544 | 1.4.1.1.6.3 | SIT CIT Full Traceability & Coverage complete |  | 118d | 2023-07-10 A | 2023-12-20 A | 543, 542 | 100% |  | 2023-07-10 | 2023-12-20 | 110d | 2023-07-10 | 2023-07-28 |  |  |  | SI Test |  | SIT | 5.0 |  | Systems Integration Testing (SIT) | Complete | COMPLETE |  |
| 545 | 1.4.1.1.6.4 | SIT Functional Full Traceability & Coverage complete |  | 138d | 2023-07-10 A | 2024-01-17 | 543, 542 | 96% | 5d | 2023-07-10 | 2024-01-17 | 138d | 2023-07-10 | 2023-09-01 | 32599d |  |  | SI Test |  | SIT | 5.0 | Roger Robar | Systems Integration Testing (SIT) | Overdue | RED |  |
| 546 | 1.4.1.2 | **Test Tool Development** |  | 256d? | 2022-10-31 A | 2023-10-23 A |  | 100% |  | 2022-10-31 | 2023-10-23 | 175d | 2022-10-31 | 2023-06-30 |  |  |  | N/A | N/A | SIT | 5.0 | N/A | Systems Integration Testing (SIT) |  |  |  |
| 547 | 1.4.1.2.1 | **Test Management Tool** |  | 256d | 2022-10-31 A | 2023-10-23 A |  | 100% |  | 2022-10-31 | 2023-10-23 | 175d | 2022-10-31 | 2023-06-30 |  |  |  | N/A | N/A | SIT | 5.0 | N/A | Systems Integration Testing (SIT) |  |  |  |
| 548 | 1.4.1.2.1.1 | **Test Management Tool Implementation** |  | 256d | 2022-10-31 A | 2023-10-23 A |  | 100% |  | 2022-10-31 | 2023-10-23 | 175d | 2022-10-31 | 2023-06-30 |  |  |  | N/A | N/A | SIT | 5.0 | N/A | Systems Integration Testing (SIT) |  |  |  |
| 549 | 1.4.1.2.1.1.1 | Requirements identification |  | 40d | 2022-10-31 A | 2022-12-23 A |  | 100% |  | 2022-10-31 | 2022-12-23 | 40d | 2022-10-31 | 2022-12-23 |  |  |  | SI DevOps | SI Test | SIT | 5.0 | Simon Berry | Systems Integration Testing (SIT) | Complete | COMPLETE |  |
| 550 | 1.4.1.2.1.1.2 | Development |  | 125d | 2023-01-02 A | 2023-06-23 A | 549FS+5d | 100% |  | 2023-01-02 | 2023-06-23 | 125d | 2023-01-02 | 2023-06-23 |  |  |  | SI DevOps | SI Test | SIT | 5.0 | Simon Berry | Systems Integration Testing (SIT) | Complete | COMPLETE |  |
| 551 | 1.4.1.2.1.1.3 | Testing |  | 125d | 2023-01-02 A | 2023-06-23 A | 550FF | 100% |  | 2023-01-02 | 2023-06-23 | 125d | 2023-01-02 | 2023-06-23 |  |  |  | SI DevOps | SI Test | SIT | 5.0 | Simon Berry | Systems Integration Testing (SIT) | Complete | COMPLETE |  |
| 552 | 1.4.1.2.1.1.4 | Accept tool | milestone | 0d | 2023-06-23 A | 2023-06-23 A | 551FF | 100% |  | 2023-06-23 | 2023-06-23 | 0d | 2023-06-23 | 2023-06-23 |  |  |  | SI DevOps | SI Test | SIT | 5.0 | Simon Berry | Systems Integration Testing (SIT) | Complete | COMPLETE |  |
| 553 | 1.4.1.2.1.1.5 | Implementation |  | 1d | 2023-10-23 A | 2023-10-23 A | 552FS+85d | 100% |  | 2023-10-23 | 2023-10-23 | 1d | 2023-06-30 | 2023-06-30 |  |  |  | SI DevOps | PPC | SIT | 5.0 | Simon Berry | Systems Integration Testing (SIT) | Complete | COMPLETE |  |
| 554 | 1.4.1.2.1.2 | **Test Management Tool User Guide** |  | 115d | 2023-01-02 A | 2023-06-09 A |  | 100% |  | 2023-01-02 | 2023-06-09 | 115d | 2023-01-02 | 2023-06-09 |  |  |  | N/A | N/A | SIT | 5.0 | N/A | Systems Integration Testing (SIT) |  |  |  |
| 555 | 1.4.1.2.1.2.1 | Develop document |  | 100d | 2023-01-02 A | 2023-05-19 A | 550SS, 551SS | 100% |  | 2023-01-02 | 2023-05-19 | 100d | 2023-01-02 | 2023-05-19 |  | start no earlier than 2023-01-02 |  | SI DevOps |  | SIT | 5.0 |  | Systems Integration Testing (SIT) | Complete | COMPLETE |  |
| 556 | 1.4.1.2.1.2.2 | Review, update and agree Test Management Tool User Guide internally |  | 15d | 2023-05-22 A | 2023-06-09 A | 555 | 100% |  | 2023-05-22 | 2023-06-09 | 15d | 2023-05-22 | 2023-06-09 |  |  |  | SRO Function | SI DevOps,SI Test,IPA,PPC | SIT | 5.0 |  | Systems Integration Testing (SIT) | Complete | COMPLETE |  |
| 557 | 1.4.1.2.1.3 | **Test Management Tool Configuration Guide** |  | 60d | 2023-01-02 A | 2023-03-24 A |  | 100% |  | 2023-01-02 | 2023-03-24 | 60d | 2023-01-02 | 2023-03-24 |  |  |  | N/A | N/A | SIT | 5.0 | N/A | Systems Integration Testing (SIT) |  |  |  |
| 558 | 1.4.1.2.1.3.1 | Develop document |  | 45d | 2023-01-02 A | 2023-03-03 A | 549 | 100% |  | 2023-01-02 | 2023-03-03 | 45d | 2023-01-02 | 2023-03-03 |  | start no earlier than 2023-01-02 |  | SI DevOps | SI Test,IPA | SIT | 5.0 |  | Systems Integration Testing (SIT) | Complete | COMPLETE |  |
| 559 | 1.4.1.2.1.3.2 | Review, update and agree Test Management Tool Configuration Guide internally |  | 15d | 2023-03-06 A | 2023-03-24 A | 558 | 100% |  | 2023-03-06 | 2023-03-24 | 15d | 2023-03-06 | 2023-03-24 |  |  |  | SRO Function | SI DevOps,SI Test,IPA | SIT | 5.0 |  | Systems Integration Testing (SIT) | Complete | COMPLETE |  |
| 560 | 1.4.1.2.2 | **Secure Volunteer SIT Participants** |  | 163d? | 2023-01-31 A | 2023-09-14 A |  | 100% |  | 2023-01-31 | 2023-09-14 | 0d |  |  |  |  |  |  |  | SIT | 6.0 |  |  | Overdue Start |  | -680.67 |
| 561 | 1.4.1.2.2.1 | PPs decide whether to volunteer to participate in SIT and inform Programme of decision via Round 3 Replan consultation |  | 1d? | 2023-01-31 A | 2023-01-31 A |  | 100% |  | 2023-01-31 | 2023-01-31 | 0d |  |  |  | finish no earlier than 2023-01-31 |  | SI Test |  | SIT | 6.0 |  |  | Complete | COMPLETE |  |
| 562 | 1.4.1.2.2.2 | Assurance of SIT volunteers' plans (submitted via Round 3 Replan Consultation) |  | 1d? | 2023-02-14 A | 2023-02-14 A |  | 100% |  | 2023-02-14 | 2023-02-14 | 0d |  |  |  | finish no earlier than 2023-02-14 |  | SI Test |  | SIT | 6.0 |  |  | Complete | COMPLETE |  |
| 563 | 1.4.1.2.2.3 | SIT Participant Volunteers Identified |  | 1d? | 2023-02-14 A | 2023-02-14 A |  | 100% |  | 2023-02-14 | 2023-02-14 | 0d |  |  |  | start no earlier than 2023-02-14 |  | SI Test |  | SIT | 6.0 |  |  | Complete | COMPLETE |  |
| 564 | 1.4.1.2.2.4 | Engagement with SIT volunteers |  | 1d? | 2023-05-23 A | 2023-05-23 A |  | 100% |  | 2023-05-23 | 2023-05-23 | 0d |  |  |  | finish no earlier than 2023-05-23 |  | SI Test |  | SIT | 6.0 |  |  | Complete | COMPLETE |  |
| 565 | 1.4.1.2.2.5 | SIT Participants Agreed |  | 1d? | 2023-05-23 A | 2023-05-23 A |  | 100% |  | 2023-05-23 | 2023-05-23 | 0d |  |  |  | start no earlier than 2023-05-23 |  | SI Test |  | SIT | 6.0 |  |  | Complete | COMPLETE |  |

| ID | WBS | Task | Type | Duration | Start | Finish | Predecessors | Complete | Baseline start | Baseline finish | Baseline duration | Baseline 1 start | Baseline 1 finish | Constraint | Responsible | Text9 | Task Status | Update Version | Sched Status | RAG | Involved | MHHS Resource Name | MHHS Programme Phase | Milestone ID | Text29 | Tier |
| --- | --- | --- | --- | --- | --- | --- | --- | --- | --- | --- | --- | --- | --- | --- | --- | --- | --- | --- | --- | --- | --- | --- | --- | --- | --- | --- |
| 566 | 1.4.1.2.2.6 | **Data Protection Impact Assessment (DPIA)** |  | 11d? | 2023-06-30 A | 2023-07-14 A |  | 100% | 2023-06-30 | 2023-07-14 | 0d |  |  |  | SI Test | SIT | -680.67 | 6.0 | Overdue Start |  |  |  |  |  |  |  |
| 567 | 1.4.1.2.2.6.1 | Conduct DPIA on Overall Test Data Approach |  | 1d? | 2023-06-30 A | 2023-06-30 A |  | 100% | 2023-06-30 | 2023-06-30 | 0d |  |  | finish no earlier than 2023-06-30 | SI Test | SIT |  | 6.0 | Complete | COMPLETE |  |  |  |  |  |  |
| 568 | 1.4.1.2.2.6.2 | Revise Overarching Test Data Approach& plan for DPIA (if required), including engagement with DWG |  | 1d? | 2023-07-13 A | 2023-07-13 A |  | 100% | 2023-07-13 | 2023-07-13 | 0d |  |  | finish no earlier than 2023-07-13 | SI Test | SIT |  | 6.0 | Complete | COMPLETE |  |  |  |  |  |  |
| 569 | 1.4.1.2.2.6.3 | Review (internal), update and approve revised Overarching Test Data Approach& Plan (if required) |  | 1d? | 2023-07-14 A | 2023-07-14 A |  | 100% | 2023-07-14 | 2023-07-14 | 0d |  |  | start no earlier than 2023-07-14 | SI Test | SIT |  | 6.0 | Complete | COMPLETE |  |  |  |  |  |  |
| 570 | 1.4.1.2.2.7 | **Data Sharing Agreements** |  | 30d? | 2023-08-04 A | 2023-09-14 A |  | 100% | 2023-08-04 | 2023-09-14 | 0d |  |  |  | SI Test | SIT | -680.67 | 6.0 | Overdue Start | COMPLETE |  |  |  |  |  |  |
| 571 | 1.4.1.2.2.7.1 | Produce Data Sharing Agreement for Industry Review |  | 1d? | 2023-08-04 A | 2023-08-04 A |  | 100% | 2023-08-04 | 2023-08-04 | 0d |  |  | finish no earlier than 2023-08-04 | SI Test | SIT |  | 6.0 | Complete | COMPLETE |  |  |  |  |  |  |
| 572 | 1.4.1.2.2.7.2 | Manage Participant Queries and Contract Agreement Execution |  | 1d? | 2023-09-14 A | 2023-09-14 A |  | 100% | 2023-09-14 | 2023-09-14 | 0d |  |  | finish no earlier than 2023-09-14 | SI Test | SIT |  | 6.0 | Complete | COMPLETE |  |  |  |  |  |  |
| 573 | 1.4.1.2.2.7.3 | Data Sharing Agreements Complete |  | 1d? | 2023-09-14 A | 2023-09-14 A |  | 100% | 2023-09-14 | 2023-09-14 | 0d |  |  | start no earlier than 2023-09-14 | SI Test | SIT |  | 6.0 | Complete | COMPLETE |  |  |  |  |  |  |
| 574 | 1.4.1.2.2.8 | **Production Data Cut & Data Obfuscation** |  | 55d? | 2023-06-19 A | 2023-09-01 A |  | 100% | 2023-06-19 | 2023-09-01 | 0d |  |  |  |  | SIT | -680.67 | 6.0 | Overdue Start | COMPLETE |  |  |  |  |  |  |
| 575 | 1.4.1.2.2.8.1 | **SI Data Cut Preparation& Infrastructure** |  | 45d? | 2023-06-19 A | 2023-08-18 A |  | 100% | 2023-06-19 | 2023-08-18 | 0d |  |  |  |  | SIT | -680.67 | 6.0 | Overdue Start | COMPLETE |  |  |  |  |  |  |
| 576 | 1.4.1.2.2.8.1.1 | SI Data Cut Planning activities (incl. pre-cut and post-cut cleansing and population approach) |  | 1d? | 2023-06-19 A | 2023-06-19 A |  | 100% | 2023-06-19 | 2023-06-19 | 0d |  |  | finish no earlier than 2023-06-19 |  | SIT |  | 6.0 | Complete | COMPLETE |  |  |  |  |  |  |
| 577 | 1.4.1.2.2.8.1.2 | Set up SI database and transmission structure |  | 1d? | 2023-08-17 A | 2023-08-17 A |  | 100% | 2023-08-17 | 2023-08-17 | 0d |  |  | finish no earlier than 2023-08-17 |  | SIT |  | 6.0 | Complete | COMPLETE |  |  |  |  |  |  |
| 578 | 1.4.1.2.2.8.1.3 | Mechanism for transfer of data in place |  | 1d? | 2023-08-18 A | 2023-08-18 A |  | 100% | 2023-08-18 | 2023-08-18 | 0d |  |  | start no earlier than 2023-08-18 |  | SIT |  | 6.0 | Complete | COMPLETE |  |  |  |  |  |  |
| 579 | 1.4.1.2.2.8.1.4 | SI Data Cut Preparation& Infrastructure Complete |  | 1d? | 2023-08-18 A | 2023-08-18 A |  | 100% | 2023-08-18 | 2023-08-18 | 0d |  |  | start no earlier than 2023-08-18 |  | SIT |  | 6.0 | Complete | COMPLETE |  |  |  |  |  |  |
| 580 | 1.4.1.2.2.8.2 | **Production Data Cut** |  | 55d? | 2023-06-19 A | 2023-09-01 A |  | 100% | 2023-06-19 | 2023-09-01 | 0d |  |  |  |  | SIT | -680.67 | 6.0 | Overdue Start | COMPLETE |  |  |  |  |  |  |
| 581 | 1.4.1.2.2.8.2.1 | Notification of Production Data Cut issued to relevant participants |  | 1d? | 2023-06-19 A | 2023-06-19 A |  | 100% | 2023-06-19 | 2023-06-19 | 0d |  |  | start no earlier than 2023-06-19 |  | SIT |  | 6.0 | Complete | COMPLETE |  |  |  |  |  |  |
| 582 | 1.4.1.2.2.8.2.2 | Coordinate relevant participants taking data cut from production systems |  | 1d? | 2023-08-11 A | 2023-08-11 A |  | 100% | 2023-08-11 | 2023-08-11 | 0d |  |  | finish no earlier than 2023-08-11 |  | SIT |  | 6.0 | Complete | COMPLETE |  |  |  |  |  |  |
| 583 | 1.4.1.2.2.8.2.3 | Production data cut GONG decision |  | 1d? | 2023-08-16 A | 2023-08-16 A |  | 100% | 2023-08-16 | 2023-08-16 | 0d |  |  | start no earlier than 2023-08-16 |  | SIT |  | 6.0 | Complete | COMPLETE |  |  |  |  |  |  |
| 584 | 1.4.1.2.2.8.2.4 | Relevant participants take data cut from production systems (Saturday 19 August) |  | 1d? | 2023-08-21 A | 2023-08-21 A |  | 100% | 2023-08-21 | 2023-08-21 | 0d |  |  | start no earlier than 2023-08-21 |  | SIT |  | 6.0 | Complete | COMPLETE |  |  |  |  |  |  |
| 585 | 1.4.1.2.2.8.2.5 | EES transmit request data to SI |  | 1d? | 2023-08-25 A | 2023-08-25 A |  | 100% | 2023-08-25 | 2023-08-25 | 0d |  |  | finish no earlier than 2023-08-25 |  | SIT |  | 6.0 | Complete | COMPLETE |  |  |  |  |  |  |
| 586 | 1.4.1.2.2.8.2.6 | Check data alignment and integrity of data cut |  | 1d? | 2023-09-01 A | 2023-09-01 A |  | 100% | 2023-09-01 | 2023-09-01 | 0d |  |  | finish no earlier than 2023-09-01 |  | SIT |  | 6.0 | Complete | COMPLETE |  |  |  |  |  |  |
| 587 | 1.4.1.2.2.8.2.7 | Data cut from relevant participants' production systems completed (Saturday 19 August) |  | 1d? | 2023-08-21 A | 2023-08-21 A |  | 100% | 2023-08-21 | 2023-08-21 | 0d |  |  | start no earlier than 2023-08-21 |  | SIT |  | 6.0 | Complete | COMPLETE |  |  |  |  |  |  |
| 588 | 1.4.1.2.2.8.2.8 | Production Data Cut Complete |  | 1d? | 2023-08-21 A | 2023-08-21 A |  | 100% | 2023-08-21 | 2023-08-21 | 0d |  |  | start no earlier than 2023-08-21 |  | SIT |  | 6.0 | Complete | COMPLETE |  |  |  |  |  |  |
| 589 | 1.4.1.3 | **SIT Participation** |  | 147d | 2022-10-31 A | 2023-05-23 A |  | 100% | 2022-10-31 | 2023-05-23 | 147d | 2022-10-31 | 2023-05-23 |  | N/A | SIT |  | 5.0 |  |  | N/A | N/A | Systems Integration Testing (SIT) |  |  |  |
| 590 | 1.4.1.3.1 | PPs decide whether to volunteer to participate in SIT and inform Programme of decision via Round 3 Replan consultation |  | 67d | 2022-10-31 A | 2023-01-31 A | 34FF | 100% | 2022-10-31 | 2023-01-31 | 67d | 2022-10-31 | 2023-01-31 |  | PP | SIT |  | 5.0 | Complete | COMPLETE | SI Test,PMO |  | Systems Integration Testing (SIT) |  |  |  |
| 591 | 1.4.1.3.2 | Assurance of SIT volunteers' plans (submitted via Round 3 Replan Consultation) |  | 10d | 2023-02-01 A | 2023-02-14 A | 590, 34 | 100% | 2023-02-01 | 2023-02-14 | 10d | 2023-02-01 | 2023-02-14 |  | SI Test | SIT |  | 5.0 | Complete | COMPLETE | PP |  | Systems Integration Testing (SIT) |  |  |  |
| 592 | 1.4.1.3.3 | SIT Participant Volunteers Identified | milestone | 0d | 2023-02-14 A | 2023-02-14 A | 591FF | 100% | 2023-02-14 | 2023-02-14 | 0d | 2023-02-14 | 2023-02-14 |  | SI Test | SIT |  | 5.0 | Complete | COMPLETE | PP |  | Systems Integration Testing (SIT) | T2-TE-0100 | SITAG | T2 |
| 593 | 1.4.1.3.4 | Engagement with SIT volunteers |  | 147d | 2022-10-31 A | 2023-05-23 A |  | 100% | 2022-10-31 | 2023-05-23 | 147d | 2022-10-31 | 2023-05-23 |  | SI Test | SIT |  | 5.0 | Complete | COMPLETE | PP |  | Systems Integration Testing (SIT) |  |  |  |
| 594 | 1.4.1.3.5 | SIT Participants Agreed | milestone | 0d | 2023-05-23 A | 2023-05-23 A | 593, 628FS-74d | 100% | 2023-05-23 | 2023-05-23 | 0d | 2023-05-23 | 2023-05-23 |  | SI Test | SIT |  | 5.0 | Complete | COMPLETE | PP |  | Systems Integration Testing (SIT) | T2-TE-0150 | SITAG | T2 |

| ID | WBS | Task | Type | Duration | Start | Finish | Predecessors | Complete | Remaining | Baseline start | Baseline finish | Baseline duration | Baseline 1 start | Baseline 1 finish | Total slack | Constraint | Baseline cost | Responsible | Involved | Text9 | Update Version | MHHS Resource Name | MHHS Programme Phase | Text29 | Sched Status | RAG | Artefact ID | Milestone ID | Tier | Task Status | Guidance |
| --- | --- | --- | --- | --- | --- | --- | --- | --- | --- | --- | --- | --- | --- | --- | --- | --- | --- | --- | --- | --- | --- | --- | --- | --- | --- | --- | --- | --- | --- | --- | --- |
| 595 | 1.4.1.4 | **SIT Stage-Specific Preparation** |  | 665d? | 2022-10-31 A | 2025-05-16 |  | 85% | 100.49d? | 2022-10-31 | 2025-05-16 | 611d | 2022-10-31 | 2025-03-10 | 32252d |  | -0 | N/A | N/A | SIT | 5.0 | N/A | Systems Integration Testing (SIT) | SITAG |  |  |  |  |  |  |  |
| 596 | 1.4.1.4.1 | **SIT Component Integration Preparation** |  | 320d | 2022-10-31 A | 2024-01-19 A |  | 100% |  | 2022-10-31 | 2024-01-19 | 321d | 2022-10-31 | 2024-01-22 |  |  | -0 | N/A | N/A | SIT | 5.0 | N/A | Systems Integration Testing (SIT) |  |  |  |  |  |  |  |  |
| 597 | 1.4.1.4.1.1 | **Test Approach & Plan** |  | 188d | 2022-10-31 A | 2023-07-19 A |  | 100% |  | 2022-10-31 | 2023-07-19 | 188d | 2022-10-31 | 2023-07-19 |  |  |  | N/A | N/A | SIT | 5.0 | N/A | Systems Integration Testing (SIT) |  |  |  |  |  |  |  |  |
| 598 | 1.4.1.4.1.1.1 | Develop document with SITWG |  | 159d | 2022-10-31 A | 2023-06-08 A |  | 100% |  | 2022-10-31 | 2023-06-08 | 159d | 2022-10-31 | 2023-05-12 |  |  |  | SI Test |  | SIT | 5.0 |  | Systems Integration Testing (SIT) |  | Complete | COMPLETE |  |  |  |  |  |
| 599 | 1.4.1.4.1.1.2 | Industry consultation |  | 10d | 2023-06-09 A | 2023-06-22 A | 598 | 100% |  | 2023-06-09 | 2023-06-22 | 10d |  |  |  |  |  | PP |  | SIT | 5.1 |  | Systems Integration Testing (SIT) |  | Complete | COMPLETE |  |  |  |  |  |
| 600 | 1.4.1.4.1.1.3 | Artefact review (via TMAG) and updates |  | 19d | 2023-06-23 A | 2023-07-19 A | 599 | 100% |  | 2023-06-23 | 2023-07-19 | 19d | 2023-06-09 | 2023-07-06 |  | finish no earlier than 2023-07-06 |  | SI Test | PP,IPA,Code Bodies | SIT | 5.0 |  | Systems Integration Testing (SIT) |  | Complete | COMPLETE |  |  |  |  |  |
| 601 | 1.4.1.4.1.1.4 | SIT Component Integration Testing Test Approach & Plan approved | milestone | 0d | 2023-07-19 A | 2023-07-19 A | 600 | 100% |  | 2023-07-19 | 2023-07-19 | 0d | 2023-07-19 | 2023-07-19 |  | finish no earlier than 2023-07-19 |  | SI Test | PP | SIT | 5.0 |  | Systems Integration Testing (SIT) | SITAG | Complete | COMPLETE | MHHS-ART073 | T3-TE-0012 | T3 |  |  |
| 602 | 1.4.1.4.1.2 | **Test Data Approach & Plan** |  | 29d | 2023-06-09 A | 2023-07-19 A |  | 100% |  | 2023-06-09 | 2023-07-19 | 29d | 2023-06-09 | 2023-07-19 |  |  |  | N/A | N/A | SIT | 5.0 | N/A | Systems Integration Testing (SIT) |  |  |  |  |  |  |  |  |
| 603 | 1.4.1.4.1.2.1 | Industry consultation |  | 10d | 2023-06-09 A | 2023-06-22 A | 599SS | 100% |  | 2023-06-09 | 2023-06-22 | 10d |  |  |  |  |  | PP |  | SIT | 5.1 | Cesar Lopes | Systems Integration Testing (SIT) |  | Complete | COMPLETE |  |  |  |  |  |
| 604 | 1.4.1.4.1.2.2 | Artefact review (via TMAG) and updates |  | 19d | 2023-06-23 A | 2023-07-19 A | 603 | 100% |  | 2023-06-23 | 2023-07-19 | 19d | 2023-06-09 | 2023-07-06 |  |  |  | SI Test | PP | SIT | 5.0 | Cesar Lopes | Systems Integration Testing (SIT) |  | Complete | COMPLETE |  |  |  |  |  |
| 605 | 1.4.1.4.1.2.3 | SIT Component Integration Testing Test Data Approach & Plan approved | milestone | 0d | 2023-07-19 A | 2023-07-19 A | 604 | 100% |  | 2023-07-19 | 2023-07-19 | 0d | 2023-07-19 | 2023-07-19 |  |  |  | SI Test | IPA | SIT | 5.0 | Cesar Lopes | Systems Integration Testing (SIT) |  | Complete | COMPLETE |  |  |  |  |  |
| 606 | 1.4.1.4.1.3 | **Test scenarios** |  | 173d | 2023-01-02 A | 2023-08-30 A |  | 100% |  | 2023-01-02 | 2023-08-30 | 173d | 2023-01-02 | 2023-06-02 |  |  |  | N/A | N/A | SIT | 5.0 | N/A | Systems Integration Testing (SIT) |  |  |  |  |  |  |  |  |
| 607 | 1.4.1.4.1.3.1 | Development of test scenarios | milestone | 0d | 2023-01-02 A | 2023-04-28 A | 598SS+45d | 100% |  | 2023-01-02 | 2023-04-28 | 85d | 2023-01-02 | 2023-04-28 |  |  |  | SI Test | PP, Code Bodies | SIT | 5.0 |  | Systems Integration Testing (SIT) |  | Complete | COMPLETE |  |  |  |  |  |
| 608 | 1.4.1.4.1.3.2 | Review test scenarios with SIT Working Group |  | 11d | 2023-02-01 A | 2023-08-09 A | 607SS+22d | 100% |  | 2023-02-01 | 2023-08-09 | 136d | 2023-02-01 | 2023-05-26 |  |  |  | SI Test | PP, Code Bodies, IPA | SIT | 5.0 |  | Systems Integration Testing (SIT) |  | Complete | COMPLETE |  |  |  |  |  |
| 609 | 1.4.1.4.1.3.3 | SIT Component Integration Testing Test scenarios approved | milestone | 0d | 2023-08-30 A | 2023-08-30 A | 608FS+15d | 100% |  | 2023-08-30 | 2023-08-30 | 0d | 2023-06-02 | 2023-06-02 |  |  |  | SI Test | PP | SIT | 5.6 |  | Systems Integration Testing (SIT) | SITAG | Complete | COMPLETE | MHHS-ART148 | T3-TE-0014 | T3 |  |  |
| 610 | 1.4.1.4.1.4 | **Test cases** |  | 160d | 2023-05-01 A | 2023-12-08 A |  | 100% |  | 2023-05-01 | 2023-12-08 | 160d | 2023-05-01 | 2023-09-01 |  |  |  | N/A | N/A | SIT | 5.6 | N/A | Systems Integration Testing (SIT) |  |  |  |  |  |  |  |  |
| 611 | 1.4.1.4.1.4.1 | **SI Test cases** |  | 160d | 2023-05-01 A | 2023-12-08 A |  | 100% |  | 2023-05-01 | 2023-12-08 | 160d | 2023-05-01 | 2023-09-01 |  |  |  | N/A | N/A | SIT | 5.6 | N/A | Systems Integration Testing (SIT) |  |  |  |  |  |  |  |  |
| 612 | 1.4.1.4.1.4.1.1 | **Batch 1 (CIT Intervals 1 and 2)** |  | 110d | 2023-05-01 A | 2023-09-29 A |  | 100% |  | 2023-05-01 | 2023-09-29 | 110d |  |  |  |  |  | N/A | N/A | SIT | 5.6 | N/A | Systems Integration Testing (SIT) |  |  |  |  |  |  | -290.67 |  |
| 613 | 1.4.1.4.1.4.1.1.1 | Develop Test cases |  | 100d | 2023-05-01 A | 2023-09-15 A | 607 | 100% |  | 2023-05-01 | 2023-09-15 | 100d | 2023-05-01 | 2023-07-28 |  |  |  | SI Test |  | SIT | 5.6 |  | Systems Integration Testing (SIT) |  | Complete | COMPLETE |  |  |  |  |  |
| 614 | 1.4.1.4.1.4.1.1.2 | Review Test cases with SIT Working Group |  | 9d | 2023-09-18 A | 2023-09-28 A | 613 | 100% |  | 2023-09-18 | 2023-09-28 | 9d | 2023-05-26 | 2023-08-25 |  |  |  | SI Test | PP,IPA | SIT | 5.6 |  | Systems Integration Testing (SIT) |  | Complete | COMPLETE |  |  |  |  |  |
| 615 | 1.4.1.4.1.4.1.1.3 | SIT Component Integration Testing Test cases Batch 1 (CIT Intervals 1 and 2) approved at ETMAG | milestone | 0d | 2023-09-29 A | 2023-09-29 A | 614FS+1d | 100% |  | 2023-09-29 | 2023-09-29 | 0d | 2023-09-01 | 2023-09-01 |  |  |  | SI Test | PP | SIT | 5.6 |  | Systems Integration Testing (SIT) | SITAG | Complete | COMPLETE | MHHS-ART073 | T3-TE-0069 | T3 |  | 18/8 - needs to finish on 29/9 for ETWAG |
| 616 | 1.4.1.4.1.4.1.2 | **Batch 2 (CIT Intervals 3 and 4)** |  | 25d | 2023-10-02 A | 2023-11-03 A |  | 100% |  | 2023-10-02 | 2023-11-03 | 25d |  |  |  |  |  | N/A | N/A | SIT | 5.6 | N/A | Systems Integration Testing (SIT) |  |  |  |  |  |  | -290.67 |  |
| 617 | 1.4.1.4.1.4.1.2.1 | Develop Test cases |  | 15d | 2023-10-02 A | 2023-10-20 A | 615 | 100% |  | 2023-10-02 | 2023-10-20 | 15d | 2023-05-01 | 2023-07-28 |  |  |  | SI Test |  | SIT | 5.6 |  | Systems Integration Testing (SIT) |  | Complete | COMPLETE |  |  |  |  |  |
| 618 | 1.4.1.4.1.4.1.2.2 | Review Test cases with SIT Working Group |  | 9d | 2023-10-23 A | 2023-11-02 A | 617 | 100% |  | 2023-10-23 | 2023-11-02 | 9d | 2023-05-26 | 2023-08-25 |  |  |  | SI Test | PP,IPA | SIT | 5.6 |  | Systems Integration Testing (SIT) |  | Complete | COMPLETE |  |  |  |  |  |
| 619 | 1.4.1.4.1.4.1.2.3 | SIT Component Integration Testing Test cases Batch 2 (CIT Intervals 3 and 4) approved at ETMAG | milestone | 0d | 2023-11-03 A | 2023-11-03 A | 618FS+1d | 100% |  | 2023-11-03 | 2023-11-03 | 0d | 2023-09-01 | 2023-09-01 |  |  |  | SI Test | PP | SIT | 5.11 |  | Systems Integration Testing (SIT) | SITAG | Complete | COMPLETE |  | T3-TE-0104 | T3 |  | 18/8 - needs to finish on 3/11 for ETWAG |

Notes:
- 615: Action: 18/8 - needs to finish on 29/9 for ETWAG. Update Milestone register after approval
- 619: Action: 18/8 - needs to finish on 29/9 for ETWAG

| ID | WBS | Task | Type | Duration | Start | Finish | Predecessors | Complete | Baseline start | Baseline finish | Baseline duration | Baseline 1 start | Baseline 1 finish | Constraint | Baseline cost | Responsible | Involved | Text9 | Task Status | Update Version | MHHS Resource Name | MHHS Programme Phase | Sched Status | RAG | Milestone ID | Text29 | Tier | Artefact ID | Action |
| --- | --- | --- | --- | --- | --- | --- | --- | --- | --- | --- | --- | --- | --- | --- | --- | --- | --- | --- | --- | --- | --- | --- | --- | --- | --- | --- | --- | --- | --- |
| 620 | 1.4.1.4.1.4.1.3 | **Batch 3 (CIT Intervals 5 and 6)** |  | 25d | 2023-11-03 A | 2023-12-08 A |  | 100% | 2023-11-03 | 2023-12-08 | 25d |  |  |  |  | N/A | N/A | SIT | -290.67 | 5.6 | N/A | Systems Integration Testing (SIT) |  |  |  |  |  |  |  |
| 621 | 1.4.1.4.1.4.1.3.1 | Develop Test cases |  | 15d | 2023-11-03 A | 2023-11-24 A | 619 | 100% | 2023-11-03 | 2023-11-24 | 15d | 2023-05-01 | 2023-07-28 |  |  | SI Test |  | SIT |  | 5.6 |  | Systems Integration Testing (SIT) | Complete | COMPLETE |  |  |  |  |  |
| 622 | 1.4.1.4.1.4.1.3.2 | Review Test cases with SIT Working Group |  | 9d | 2023-11-27 A | 2023-12-07 A | 621 | 100% | 2023-11-27 | 2023-12-07 | 9d | 2023-05-26 | 2023-08-25 |  |  | SI Test | PP,IPA | SIT |  | 5.6 |  | Systems Integration Testing (SIT) | Complete | COMPLETE |  |  |  |  |  |
| 623 | 1.4.1.4.1.4.1.3.3 | SIT Component Integration Testing Test cases Batch 3 (CIT Intervals 5 and 6) approved at ETMAG | milestone | 0d | 2023-12-08 A | 2023-12-08 A | 622FS+1d | 100% | 2023-12-08 | 2023-12-08 | 0d | 2023-09-01 | 2023-09-01 |  |  | SI Test | PP | SIT |  | 5.14 |  | Systems Integration Testing (SIT) | Complete | COMPLETE | T3-TE-0105 | SITAG | T3 |  |  |
| 624 | 1.4.1.4.1.5 | **CIT Interval 1 Preparation** |  | 283d | 2022-11-16 A | 2023-12-15 A |  | 100% | 2022-11-16 | 2023-12-15 | 278d | 2022-11-16 | 2023-10-23 |  | -0 | N/A | N/A | SIT |  | 5.6 | N/A | Systems Integration Testing (SIT) |  |  |  |  |  |  |  |
| 625 | 1.4.1.4.1.5.1 | **Environments (SIT A)** |  | 246d | 2022-11-16 A | 2023-10-25 A |  | 100% | 2022-11-16 | 2023-10-25 | 239d | 2022-11-16 | 2023-10-06 |  |  | N/A | N/A | SIT |  | 5.0 | N/A | Systems Integration Testing (SIT) |  |  |  |  |  |  |  |
| 626 | 1.4.1.4.1.5.1.1 | PPs register PKI Officers and request PKI certificates |  | 5d | 2023-10-09 A | 2023-10-13 A |  | 100% | 2023-10-09 | 2023-10-13 | 5d | 2023-08-28 | 2023-09-01 | start no earlier than 2023-10-09 |  | PP | DIP Provider | SIT |  | 5.5 | Simon Berry | Systems Integration Testing (SIT) | Complete | COMPLETE |  |  |  |  |  |
| 627 | 1.4.1.4.1.5.1.2 | PPs register PKI Officers and request PKI certificates Complete - Interval 1 | milestone | 0d | 2023-10-25 A | 2023-10-25 A | 626FS+8d | 100% | 2023-10-25 | 2023-10-25 | 0d |  |  |  |  | PP | DIP Provider | SIT |  | 5.10 | Simon Berry | Systems Integration Testing (SIT) | Complete | COMPLETE | T3-TE-0094 | SITAG | T3 |  |  |
| 628 | 1.4.1.4.1.5.1.3 | PP SIT A environment preparation (incl. security certificates and security compliance) |  | 238d | 2022-11-16 A | 2023-10-13 A | 517 | 100% | 2022-11-16 | 2023-10-13 | 208d | 2022-11-16 | 2023-09-01 |  |  | PP | SI Test | SIT |  | 5.8 | Simon Berry | Systems Integration Testing (SIT) | Complete | COMPLETE |  |  |  |  |  |
| 629 | 1.4.1.4.1.5.1.4 | SI coordinate SIT Participants' SIT A environment preparation |  | 238d | 2022-11-16 A | 2023-10-13 A | 628SS | 100% | 2022-11-16 | 2023-10-13 | 208d | 2022-11-16 | 2023-09-01 |  |  | SI Test | PP | SIT |  | 5.8 | Simon Berry | Systems Integration Testing (SIT) | Complete | COMPLETE |  |  |  |  |  |
| 630 | 1.4.1.4.1.5.1.5 | PP submit self-declaration of environment preparation complete (incl. security certificates and security compliance) to Programme for assurance | milestone | 0d | 2023-10-13 A | 2023-10-13 A | 628FF | 100% | 2023-10-13 | 2023-10-13 | 0d | 2023-09-01 | 2023-09-01 | start no earlier than 2023-10-13 |  | PP | SI Test | SIT |  | 5.8 | Simon Berry | Systems Integration Testing (SIT) | Complete | COMPLETE |  |  |  |  |  |
| 631 | 1.4.1.4.1.5.1.6 | SI assure PPs' self-declaration of environment preparation complete (incl. security certificates and security compliance) |  | 5d | 2023-10-16 A | 2023-10-20 A | 630FF+5d | 100% | 2023-10-16 | 2023-10-20 | 5d | 2023-09-04 | 2023-09-08 |  |  | SI Test | PP | SIT |  | 5.8 | Simon Berry | Systems Integration Testing (SIT) | Complete | COMPLETE |  |  |  |  |  |
| 632 | 1.4.1.4.1.5.1.7 | SIT Participants' SIT A environments ready to start connectivity proving CIT Interval 1 | milestone | 0d | 2023-09-01 A | 2023-09-01 A | 630SS | 100% | 2023-09-01 | 2023-09-01 | 0d | 2023-09-01 | 2023-09-01 |  |  | PP | PP,IPA | SIT |  | 5.6 | Simon Berry | Systems Integration Testing (SIT) | Complete | COMPLETE | T3-TE-0019 | SITAG | T3 | MHHS-ART139 |  |
| 633 | 1.4.1.4.1.5.1.8 | PP SIT A environment connectivity proving |  | 10d | 2023-09-04 A | 2023-09-15 A | 632 | 100% | 2023-09-04 | 2023-09-15 | 20d | 2023-09-04 | 2023-09-29 |  |  | PP | SI Test | SIT |  | 5.8 | Simon Berry | Systems Integration Testing (SIT) | Complete | COMPLETE |  |  |  |  |  |
| 634 | 1.4.1.4.1.5.1.9 | SI coordinate SIT Participants' SIT A environment connectivity proving |  | 10d | 2023-09-04 A | 2023-09-15 A | 633SS | 100% | 2023-09-04 | 2023-09-15 | 20d | 2023-09-04 | 2023-09-29 |  |  | SI Test | PP | SIT |  | 5.8 | Simon Berry | Systems Integration Testing (SIT) | Complete | COMPLETE |  |  |  |  |  |
| 635 | 1.4.1.4.1.5.1.10 | PP deployment of MHHS solution code to SIT A environments |  | 10d | 2023-09-25 A | 2023-10-06 A | 676FF | 100% | 2023-09-25 | 2023-10-06 | 10d | 2023-09-18 | 2023-09-29 |  |  | PP | SI Test | SIT |  | 5.0 | Simon Berry | Systems Integration Testing (SIT) | Complete | COMPLETE |  |  |  |  |  |
| 636 | 1.4.1.4.1.5.1.11 | SI coordinate deployment of MHHS solution code to SIT Participants' SIT A environments |  | 10d | 2023-09-25 A | 2023-10-06 A | 676FF | 100% | 2023-09-25 | 2023-10-06 | 10d | 2023-09-18 | 2023-09-29 |  |  | SI Test | PP | SIT |  | 5.0 | Simon Berry | Systems Integration Testing (SIT) | Complete | COMPLETE |  |  |  |  |  |
| 637 | 1.4.1.4.1.5.1.12 | PP submit evidence of SIT A environment connectivity proving and code deployment completion to Programme for assurance |  | 30d | 2023-09-04 A | 2023-10-13 A | 633SS | 100% | 2023-09-04 | 2023-10-13 | 20d | 2023-09-04 | 2023-09-29 |  |  | PP | SI Test | SIT |  | 5.8 | Simon Berry | Systems Integration Testing (SIT) | Complete | COMPLETE |  |  |  |  |  |
| 638 | 1.4.1.4.1.5.1.13 | SI assurance of SIT Participants' SIT A environment connectivity proving and code deployment completion |  | 25d | 2023-09-18 A | 2023-10-20 A | 637FF+5d | 100% | 2023-09-18 | 2023-10-20 | 25d | 2023-09-04 | 2023-10-06 |  |  | SI Test | PP | SIT |  | 5.8 | Simon Berry | Systems Integration Testing (SIT) | Complete | COMPLETE |  |  |  |  |  |
| 639 | 1.4.1.4.1.5.2 | **Test Data - ISD Creation** |  | 9d | 2023-08-22 A | 2023-09-01 A |  | 100% | 2023-08-22 | 2023-09-01 | 9d |  |  |  |  | N/A | N/A | SIT | -275.67 | 5.5 | N/A | Systems Integration Testing (SIT) |  |  |  |  |  |  |  |
| 640 | 1.4.1.4.1.5.2.1 | Set-up Market Participants and DIP ID Data |  | 8d | 2023-08-22 A | 2023-08-31 A |  | 100% | 2023-08-22 | 2023-08-31 | 8d |  |  |  |  | SI Test Data | SI Test, DIP, Helix | SIT |  | 5.5 | Cesar Lopes | Systems Integration Testing (SIT) | Complete | COMPLETE |  |  |  |  |  |
| 641 | 1.4.1.4.1.5.2.2 | Distribute ISD Data to Participants |  | 1d | 2023-09-01 A | 2023-09-01 A | 640 | 100% | 2023-09-01 | 2023-09-01 | 1d |  |  |  |  | SI Test Data | SI Test, DIP, Helix | SIT |  | 5.5 | Cesar Lopes | Systems Integration Testing (SIT) | Complete | COMPLETE |  |  |  |  |  |
| 642 | 1.4.1.4.1.5.2.3 | Test Data - ISD Creation Complete | milestone | 0d | 2023-09-01 A | 2023-09-01 A | 641 | 100% | 2023-09-01 | 2023-09-01 | 0d |  |  |  |  | SI Test Data | SI Test, DIP, Helix | SIT |  | 5.5 | Cesar Lopes | Systems Integration Testing (SIT) | Complete | COMPLETE | T3-TE-0083 | SITAG | T3 |  | 3/8 - add as t3 milestones. Awaiting approval at TMAG |
| 643 | 1.4.1.4.1.5.3 | **Test Data - SFTP Onboarding** |  | 70d | 2023-08-21 A | 2023-11-24 A |  | 100% | 2023-08-21 | 2023-11-24 | 70d |  |  |  | -0 | N/A | N/A | SIT | -275.67 | 5.5 | N/A | Systems Integration Testing (SIT) |  |  |  |  |  |  |  |
| 644 | 1.4.1.4.1.5.3.1 | Create Containers and Keys for Participants |  | 3d | 2023-08-21 A | 2023-08-23 A |  | 100% | 2023-08-21 | 2023-08-23 | 3d |  |  |  |  | SI Test Data | SI Test | SIT |  | 5.5 | Cesar Lopes | Systems Integration Testing (SIT) | Complete | COMPLETE |  |  |  |  |  |
| 645 | 1.4.1.4.1.5.3.2 | Share SFTP Access with Participants |  | 5d | 2023-08-24 A | 2023-08-30 A | 644 | 100% | 2023-08-24 | 2023-08-30 | 5d |  |  |  |  | SI Test Data | SI Test, PP | SIT |  | 5.5 | Cesar Lopes | Systems Integration Testing (SIT) | Complete | COMPLETE |  |  |  |  |  |
| 646 | 1.4.1.4.1.5.3.3 | Test SFTP Connectivity |  | 5d | 2023-08-31 A | 2023-09-06 A | 645 | 100% | 2023-08-31 | 2023-09-06 | 5d |  |  |  |  | SI Test Data | SI Test, PP | SIT |  | 5.5 | Cesar Lopes | Systems Integration Testing (SIT) | Complete | COMPLETE |  |  |  |  |  |
| 647 | 1.4.1.4.1.5.3.4 | Test Data - SFTP Onboarding Complete | milestone | 0d | 2023-11-24 A | 2023-11-24 A | 646FS+57d | 100% | 2023-11-24 | 2023-11-24 | 0d |  |  |  |  | SI Test Data | SI Test, PP | SIT |  | 5.13 | Cesar Lopes | Systems Integration Testing (SIT) | Complete | COMPLETE | T3-TE-0084 | SITAG | T3 |  |  |

Notes:
- 623: Guidance: 28/11 - Red because TMAG date has moved from 8/12 to 20/12 due to reduction in Dec TMAGs. No impact. No action

| ID | WBS | Task | Type | Duration | Start | Finish | Predecessors | Complete | Baseline start | Baseline finish | Baseline duration | Baseline 1 start | Baseline 1 finish | Baseline cost | Responsible | Involved | Text9 | Task Status | Update Version | MHHS Resource Name | MHHS Programme Phase | Sched Status | RAG | Milestone ID | Text29 | Tier | Artefact ID |
| --- | --- | --- | --- | --- | --- | --- | --- | --- | --- | --- | --- | --- | --- | --- | --- | --- | --- | --- | --- | --- | --- | --- | --- | --- | --- | --- | --- |
| 648 | 1.4.1.4.1.5.4 | **Test Data - Provide Sample Files** |  | 10d | 2023-08-21 A | 2023-09-01 A |  | 100% | 2023-08-21 | 2023-09-01 | 10d |  |  |  | N/A | N/A | SIT | -275.67 | 5.5 | N/A | Systems Integration Testing (SIT) |  |  |  |  |  |  |
| 649 | 1.4.1.4.1.5.4.1 | Generate Sample Files off IF Messages |  | 8d | 2023-08-21 A | 2023-08-30 A |  | 100% | 2023-08-21 | 2023-08-30 | 8d |  |  |  | SI Test Data | SI Test | SIT |  | 5.5 | Cesar Lopes | Systems Integration Testing (SIT) | Complete | COMPLETE |  |  |  |  |
| 650 | 1.4.1.4.1.5.4.2 | Transmit Sample Files off IF Messages to Participants (More detail needs to be planned for a POC) |  | 2d | 2023-08-31 A | 2023-09-01 A | 649 | 100% | 2023-08-31 | 2023-09-01 | 2d |  |  |  | SI Test Data | SI Test | SIT |  | 5.5 | Cesar Lopes | Systems Integration Testing (SIT) | Complete | COMPLETE |  |  |  |  |
| 651 | 1.4.1.4.1.5.4.3 | Test Data - Provide Sample Files Complete | milestone | 0d | 2023-09-01 A | 2023-09-01 A | 650 | 100% | 2023-09-01 | 2023-09-01 | 0d |  |  |  | SI Test Data | SI Test | SIT |  | 5.5 | Cesar Lopes | Systems Integration Testing (SIT) | Complete | COMPLETE | T3-TE-0085 | SITAG | T3 |  |
| 652 | 1.4.1.4.1.5.5 | **Test Data - Detailed SIT Data Load Guidance** |  | 65d | 2023-09-07 A | 2023-12-06 A |  | 100% | 2023-09-07 | 2023-12-06 | 62d |  |  | -0 | N/A | N/A | SIT | -275.67 | 5.5 | N/A | Systems Integration Testing (SIT) |  |  |  |  |  |  |
| 653 | 1.4.1.4.1.5.5.1 | Document Guidance |  | 21d | 2023-09-07 A | 2023-10-05 A | 651FS+3d | 100% | 2023-09-07 | 2023-10-05 | 16d |  |  |  | SI Test Data | SI Test | SIT |  | 5.9 | Cesar Lopes | Systems Integration Testing (SIT) | Complete | COMPLETE |  |  |  |  |
| 654 | 1.4.1.4.1.5.5.2 | Provide Guidance to PPs |  | 1d | 2023-10-06 A | 2023-10-06 A | 653 | 100% | 2023-10-06 | 2023-10-06 | 1d |  |  |  | SI Test Data | SI Test | SIT |  | 5.9 | Cesar Lopes | Systems Integration Testing (SIT) | Complete | COMPLETE |  |  |  |  |
| 655 | 1.4.1.4.1.5.5.3 | Test Data - Detailed SIT Functional Data Load Guidance Complete | milestone | 0d | 2023-12-06 A | 2023-12-06 A | 654FS+43d | 100% | 2023-12-06 | 2023-12-06 | 0d |  |  |  | SI Test Data | SI Test | SIT |  | 5.13 | Richard Puddephatt | Systems Integration Testing (SIT) | Complete | COMPLETE | T3-TE-0095 | SITAG | T3 | MHHS-DEL 1545 |
| 656 | 1.4.1.4.1.5.6 | **Test Data - Population of Data Items for Testing Guidance - Draft** |  | 80d | 2023-08-17 A | 2023-12-06 A |  | 100% | 2023-08-17 | 2023-12-06 | 77d |  |  | -0 | N/A | N/A | SIT | -275.67 | 5.5 | N/A | Systems Integration Testing (SIT) |  |  |  |  |  |  |
| 657 | 1.4.1.4.1.5.6.1 | Document Guidance - Draft |  | 11d | 2023-08-17 A | 2023-08-31 A | 846 | 100% | 2023-08-17 | 2023-08-31 | 11d |  |  |  | SI Test Data | SI Test | SIT |  | 5.6 | Cesar Lopes | Systems Integration Testing (SIT) | Complete | COMPLETE |  |  |  |  |
| 658 | 1.4.1.4.1.5.6.2 | Provide Guidance to PPs - Draft |  | 1d | 2023-09-01 A | 2023-09-01 A | 657 | 100% | 2023-09-01 | 2023-09-01 | 1d |  |  |  | SI Test Data | SI Test | SIT |  | 5.6 | Cesar Lopes | Systems Integration Testing (SIT) | Complete | COMPLETE |  |  |  |  |
| 659 | 1.4.1.4.1.5.6.3 | Test Data - Population of Data Items for Testing Guidance - Draft Complete | milestone | 0d | 2023-12-06 A | 2023-12-06 A | 658FS+68d | 100% | 2023-12-06 | 2023-12-06 | 0d |  |  |  | SI Test Data | SI Test | SIT |  | 5.13 | Richard Puddephatt | Systems Integration Testing (SIT) | Complete | COMPLETE | T3-TE-0096 | SITAG | T3 | MHHS-DEL 816 |
| 660 | 1.4.1.4.1.5.7 | **Test Data - Population of Data Items for Testing Guidance - Final** |  | 87d | 2023-08-17 A | 2023-12-15 A |  | 100% | 2023-08-17 | 2023-12-15 | 45d |  |  |  | N/A | N/A | SIT | -275.67 | 5.5 | N/A | Systems Integration Testing (SIT) |  |  |  |  |  |  |
| 661 | 1.4.1.4.1.5.7.1 | Update Document Guidance With PPS Feedback |  | 81d | 2023-08-17 A | 2023-12-07 A | 657SS | 100% | 2023-08-17 | 2023-12-07 | 44d |  |  |  | SI Test Data | SI Test | SIT |  | 5.5 | Richard Puddephatt | Systems Integration Testing (SIT) | Complete | COMPLETE |  |  |  |  |
| 662 | 1.4.1.4.1.5.7.2 | Provide Final Guidance to PPs |  | 1d | 2023-12-08 A | 2023-12-08 A | 661 | 100% | 2023-12-08 | 2023-12-08 | 1d |  |  |  | SI Test Data | SI Test | SIT |  | 5.5 | Richard Puddephatt | Systems Integration Testing (SIT) | Complete | COMPLETE |  |  |  |  |
| 663 | 1.4.1.4.1.5.7.3 | Test Data - Population of Data Items for Testing Guidance - Final Complete | milestone | 0d | 2023-12-15 A | 2023-12-15 A | 662FS+5d | 100% | 2023-12-15 | 2023-12-15 | 0d |  |  |  | SI Test Data | SI Test | SIT |  | 5.14 | Richard Puddephatt | Systems Integration Testing (SIT) | Complete | COMPLETE | T3-TE-0097 | SITAG | T3 | MHHS-DEL 816 |
| 664 | 1.4.1.4.1.5.8 | **Test Data (SIT A) Interval 1** |  | 40d | 2023-09-04 A | 2023-10-27 A |  | 100% | 2023-09-04 | 2023-10-27 | 20d | 2023-09-04 | 2023-09-29 |  | N/A | N/A | SIT |  | 5.0 | N/A | Systems Integration Testing (SIT) |  |  |  |  |  |  |
| 665 | 1.4.1.4.1.5.8.1 | Run data allocation |  | 4d | 2023-09-04 A | 2023-09-07 A | 605, 642 | 100% | 2023-09-04 | 2023-09-07 | 4d | 2023-09-04 | 2023-09-07 |  | SI Test |  | SIT |  | 5.0 | Cesar Lopes | Systems Integration Testing (SIT) | Complete | COMPLETE |  |  |  |  |
| 666 | 1.4.1.4.1.5.8.2 | Cleanse, anonymise and populate data post cut |  | 4d | 2023-09-08 A | 2023-09-13 A | 665 | 100% | 2023-09-08 | 2023-09-13 | 4d | 2023-09-08 | 2023-09-13 |  | SI Test |  | SIT |  | 5.0 | Cesar Lopes | Systems Integration Testing (SIT) | Complete | COMPLETE |  |  |  |  |
| 667 | 1.4.1.4.1.5.8.3 | Transmit data sets to PPs |  | 3d | 2023-09-15 A | 2023-09-19 A | 666 | 100% | 2023-09-15 | 2023-09-19 | 1d | 2023-09-14 | 2023-09-15 |  | SI Test |  | SIT |  | 5.0 | Cesar Lopes | Systems Integration Testing (SIT) | Complete | COMPLETE |  |  |  |  |
| 668 | 1.4.1.4.1.5.8.4 | PP - Load test data to test environments |  | 7d | 2023-09-20 A | 2023-09-28 A | 667, 651 | 100% | 2023-09-20 | 2023-09-28 | 5d | 2023-09-18 | 2023-09-22 |  | PP |  | SIT |  | 5.0 | Cesar Lopes | Systems Integration Testing (SIT) | Complete | COMPLETE |  |  |  |  |
| 669 | 1.4.1.4.1.5.8.5 | PP Check data integrity on test environment |  | 1d | 2023-09-29 A | 2023-09-29 A | 668 | 100% | 2023-09-29 | 2023-09-29 | 5d | 2023-09-25 | 2023-09-29 |  | PP |  | SIT |  | 5.0 | Cesar Lopes | Systems Integration Testing (SIT) | Complete | COMPLETE |  |  |  |  |
| 670 | 1.4.1.4.1.5.8.6 | PP submit self-declaration to Programme to confirm loading & verification of test data | milestone | 0d | 2023-09-29 A | 2023-09-29 A | 669FF | 100% | 2023-09-29 | 2023-09-29 | 0d | 2023-09-29 | 2023-09-29 |  | PP | SI Test | SIT |  | 5.0 | Cesar Lopes | Systems Integration Testing (SIT) | Complete | COMPLETE |  |  |  |  |
| 671 | 1.4.1.4.1.5.8.7 | Test Data (SIT A) Interval 1 Complete | milestone | 0d | 2023-10-27 A | 2023-10-27 A | 670FS+20d | 100% | 2023-10-27 | 2023-10-27 | 0d |  |  |  | SI Test | PP | SIT |  | 5.10 | Cesar Lopes | Systems Integration Testing (SIT) | Complete | COMPLETE | T3-TE-0073 | SITAG | T3 | MHHS-ART148/169 |

Notes:
- 651: Action: 3/8 - add as t3 milestones. Awaiting approval at TMAG
- 671: Action: 28/7: CH: Needs to be set-up as a reporting milestone. 31/7: Check with Cesar if has been approved so can be baselined

| ID | WBS | Task | Type | Duration | Start | Finish | Predecessors | Complete | Baseline start | Baseline finish | Baseline duration | Baseline 1 start | Baseline 1 finish | Constraint | Baseline cost | Responsible | Involved | Text9 | Update Version | MHHS Resource Name | MHHS Programme Phase | Sched Status | RAG | Artefact ID | Milestone ID | Text29 | Tier |
| --- | --- | --- | --- | --- | --- | --- | --- | --- | --- | --- | --- | --- | --- | --- | --- | --- | --- | --- | --- | --- | --- | --- | --- | --- | --- | --- | --- |
| 672 | 1.4.1.4.1.5.9 | **Other Preparation** |  | 45d | 2023-07-03 A | 2023-09-01 A |  | 100% | 2023-07-03 | 2023-09-01 | 45d | 2023-07-03 | 2023-09-01 |  |  | N/A | N/A | SIT | 5.0 | N/A | Systems Integration Testing (SIT) |  |  |  |  |  |  |
| 673 | 1.4.1.4.1.5.9.1 | Onboarding of Test Participants to Test Management Tool (Azure DevOps) |  | 45d | 2023-07-03 A | 2023-09-01 A | 632SF | 100% | 2023-07-03 | 2023-09-01 | 45d | 2023-07-03 | 2023-09-01 |  |  | SI Test | PP | SIT | 5.0 |  | Systems Integration Testing (SIT) | Complete | COMPLETE |  |  |  |  |
| 674 | 1.4.1.4.1.5.9.2 | Test Management Tool onboarding |  | 45d | 2023-07-03 A | 2023-09-01 A | 632SF | 100% | 2023-07-03 | 2023-09-01 | 45d | 2023-07-03 | 2023-09-01 |  |  | PP | SI Test | SIT | 5.0 |  | Systems Integration Testing (SIT) | Complete | COMPLETE |  |  |  |  |
| 675 | 1.4.1.4.1.5.10 | **SIT Component Integration Test Readiness Report** |  | 28d | 2023-09-14 A | 2023-10-23 A |  | 100% | 2023-09-14 | 2023-10-23 | 9d | 2023-09-11 | 2023-10-20 |  |  | N/A | N/A | SIT | 5.6 | N/A | Systems Integration Testing (SIT) |  |  |  |  |  |  |
| 676 | 1.4.1.4.1.5.10.1 | PP submit Test Readiness Report to Programme for assurance | milestone | 0d | 2023-10-20 A | 2023-10-20 A | 674, 615, 671 | 100% | 2023-10-20 | 2023-10-20 | 0d | 2023-09-29 | 2023-09-29 | start no earlier than 2023-10-09 |  | PP | SI Test | SIT | 5.6 |  | Systems Integration Testing (SIT) | Complete | COMPLETE |  |  |  |  |
| 677 | 1.4.1.4.1.5.10.2 | SI assure Test Participants' Test Readiness Reports |  | 1d | 2023-10-23 A | 2023-10-23 A | 676SS | 100% | 2023-10-23 | 2023-10-23 | 5d | 2023-10-02 | 2023-10-06 |  |  | SI Test | PP,IPA | SIT | 5.6 |  | Systems Integration Testing (SIT) | Complete | COMPLETE |  |  |  |  |
| 678 | 1.4.1.4.1.5.10.3 | SI develop Overarching SIT Component Integration Test Readiness Report |  | 23d | 2023-09-14 A | 2023-10-16 A | 601FS+40d | 100% | 2023-09-14 | 2023-10-16 | 4d | 2023-09-11 | 2023-10-06 |  |  | SI Test |  | SIT | 5.6 |  | Systems Integration Testing (SIT) | Complete | COMPLETE |  |  |  |  |
| 679 | 1.4.1.4.1.5.10.4 | Artefact review (via TMAG) and updates |  | 4d | 2023-10-17 A | 2023-10-20 A | 678 | 100% | 2023-10-17 | 2023-10-20 | 5d | 2023-10-09 | 2023-10-20 |  |  | SI Test | PP,IPA | SIT | 5.6 |  | Systems Integration Testing (SIT) | Complete | COMPLETE |  |  |  |  |
| 680 | 1.4.1.4.1.5.11 | SIT Component Integration Testing 1 Preparation Complete (incl. approval of SI SIT Component Integration Test Readiness Report) | milestone | 0d | 2023-10-27 A | 2023-10-27 A | 679FS+1d, 676, 632, 674, 671, 248, 253, 242, 262, 263, 677 | 100% | 2023-10-27 | 2023-10-27 | 0d | 2023-10-23 | 2023-10-23 |  |  | SI Test | PP,IPA | SIT | 5.11 |  | Systems Integration Testing (SIT) | Complete | COMPLETE | MHHS-ART071 | T2-TE-0250 | SITAG | T2 |
| 681 | 1.4.1.4.1.6 | **CIT Interval 2 Preparation** |  | 103d | 2023-07-03 A | 2023-11-22 A |  | 100% | 2023-07-03 | 2023-11-22 | 95d | 2022-11-16 | 2023-11-06 |  | -0 | N/A | N/A | SIT | 5.0 | N/A | Systems Integration Testing (SIT) |  |  |  |  |  |  |
| 682 | 1.4.1.4.1.6.1 | **Environments (SIT A)** |  | 43d | 2023-09-22 A | 2023-11-22 A |  | 100% | 2023-09-22 | 2023-11-22 | 35d | 2022-11-16 | 2023-10-27 |  | -0 | N/A | N/A | SIT | 5.0 | N/A | Systems Integration Testing (SIT) |  |  |  |  |  |  |
| 683 | 1.4.1.4.1.6.1.1 | SIT Participants' SIT A environments ready to start connectivity proving CIT Interval 2 | milestone | 0d | 2023-09-22 A | 2023-09-22 A |  | 100% | 2023-09-22 | 2023-09-22 | 0d | 2023-09-22 | 2023-09-22 |  |  | PP | PP,IPA | SIT | 5.6 | Simon Berry | Systems Integration Testing (SIT) | Complete | COMPLETE | MHHS-ART139 | T3-TE-0020 | SITAG | T3 |
| 684 | 1.4.1.4.1.6.1.2 | Programme Participants Ready to Start Connectivity Proving | milestone | 0d | 2023-09-22 A | 2023-09-22 A |  | 100% | 2023-09-22 | 2023-09-22 | 0d |  |  | finish no earlier than 2023-09-22 |  | PP |  | SIT | 5.10 | Simon Berry | Systems Integration Testing (SIT) | Complete | COMPLETE |  |  |  |  |
| 685 | 1.4.1.4.1.6.1.3 | Internal Connectivity Proving Phase |  | 10d | 2023-09-25 A | 2023-10-06 A | 684 | 100% | 2023-09-25 | 2023-10-06 | 10d |  |  |  |  | PP |  | SIT | 5.10 | Simon Berry | Systems Integration Testing (SIT) | Complete | COMPLETE |  |  |  |  |
| 686 | 1.4.1.4.1.6.1.4 | Internal Connectivity Proving Phase Complete | milestone | 0d | 2023-10-06 A | 2023-10-06 A | 685 | 100% | 2023-10-06 | 2023-10-06 | 0d |  |  | start no earlier than 2023-10-06 |  | PP |  | SIT | 5.10 | Simon Berry | Systems Integration Testing (SIT) | Complete | COMPLETE |  |  |  |  |
| 687 | 1.4.1.4.1.6.1.5 | DIP Onboarding Activity (1. PKI Officers and Certificates, 2. Set-up Validation, 3. End Point Creation, 4. Controlled Smoke Test ) |  | 28d | 2023-10-16 A | 2023-11-22 A | 686FS+5d | 100% | 2023-10-16 | 2023-11-22 | 20d |  |  |  |  | PP |  | SIT | 5.10 | Simon Berry | Systems Integration Testing (SIT) | Complete | COMPLETE |  |  |  |  |
| 688 | 1.4.1.4.1.6.1.6 | DIP Onboarding Complete | milestone | 0d | 2023-11-22 A | 2023-11-22 A | 687 | 100% | 2023-11-22 | 2023-11-22 | 0d |  |  |  |  | PP |  | SIT | 5.10 | Simon Berry | Systems Integration Testing (SIT) | Complete | COMPLETE |  |  |  |  |
| 689 | 1.4.1.4.1.6.1.7 | PPs Register PKI Officers and request PKI certificates Complete - Interval 2 | milestone | 0d | 2023-11-22 A | 2023-11-22 A | 688 | 100% | 2023-11-22 | 2023-11-22 | 0d |  |  |  |  | PP | DIP Provider | SIT | 5.15 | Simon Berry | Systems Integration Testing (SIT) | Complete | COMPLETE |  | T3-TE-0098 | SITAG | T3 |
| 690 | 1.4.1.4.1.6.1.8 | PP Code Deployment | milestone | 0d | 2023-10-20 A | 2023-10-20 A |  | 100% | 2023-10-20 | 2023-10-20 | 0d |  |  | start no earlier than 2023-10-20 |  | PP |  | SIT | 5.10 | Simon Berry | Systems Integration Testing (SIT) | Complete | COMPLETE |  |  |  |  |
| 691 | 1.4.1.4.1.6.2 | **Test Data (SIT A) Interval 2** |  | 43d | 2023-09-20 A | 2023-11-17 A |  | 100% | 2023-09-20 | 2023-11-17 | 25d | 2023-09-18 | 2023-10-20 |  |  | N/A | N/A | SIT | 5.0 | N/A | Systems Integration Testing (SIT) |  |  |  |  |  |  |
| 692 | 1.4.1.4.1.6.2.1 | Run data allocation |  | 7d | 2023-09-20 A | 2023-09-28 A | 668SS | 100% | 2023-09-20 | 2023-09-28 | 5d | 2023-09-18 | 2023-09-22 |  |  | SI Test |  | SIT | 5.0 | Cesar Lopes | Systems Integration Testing (SIT) | Complete | COMPLETE |  |  |  |  |
| 693 | 1.4.1.4.1.6.2.2 | Cleanse and populate data post cut |  | 2d | 2023-09-29 A | 2023-10-02 A | 692 | 100% | 2023-09-29 | 2023-10-02 | 5d | 2023-09-25 | 2023-09-29 |  |  | SI Test |  | SIT | 5.0 | Cesar Lopes | Systems Integration Testing (SIT) | Complete | COMPLETE |  |  |  |  |
| 694 | 1.4.1.4.1.6.2.3 | Transmit data sets to PPs |  | 1d | 2023-10-03 A | 2023-10-03 A | 693 | 100% | 2023-10-03 | 2023-10-03 | 2d | 2023-10-02 | 2023-10-03 |  |  | SI Test |  | SIT | 5.0 | Cesar Lopes | Systems Integration Testing (SIT) | Complete | COMPLETE |  |  |  |  |
| 695 | 1.4.1.4.1.6.2.4 | PP - Load test data to test environments |  | 33d | 2023-10-04 A | 2023-11-17 A | 694 | 100% | 2023-10-04 | 2023-11-17 | 8d | 2023-10-04 | 2023-10-13 |  |  | PP |  | SIT | 5.0 | Cesar Lopes | Systems Integration Testing (SIT) | Complete | COMPLETE |  |  |  |  |
| 696 | 1.4.1.4.1.6.2.5 | PP Check data integrity on test environment |  | 15d | 2023-10-23 A | 2023-11-17 A | 695FF | 100% | 2023-10-23 | 2023-11-17 | 5d | 2023-10-16 | 2023-10-20 |  |  | PP |  | SIT | 5.0 | Cesar Lopes | Systems Integration Testing (SIT) | Complete | COMPLETE |  |  |  |  |
| 697 | 1.4.1.4.1.6.2.6 | PP submit self-declaration to Programme to confirm loading & verification of test data | milestone | 0d | 2023-11-17 A | 2023-11-17 A | 696FF | 100% | 2023-11-17 | 2023-11-17 | 0d | 2023-10-20 | 2023-10-20 |  |  | PP | SI Test | SIT | 5.0 | Cesar Lopes | Systems Integration Testing (SIT) | Complete | COMPLETE |  |  |  |  |
| 698 | 1.4.1.4.1.6.2.7 | Test Data (SIT A) Interval 2 Complete | milestone | 0d | 2023-11-17 A | 2023-11-17 A | 697 | 100% | 2023-11-17 | 2023-11-17 | 0d |  |  |  |  | SI Test | PP | SIT | 5.12 | Cesar Lopes | Systems Integration Testing (SIT) | Complete | COMPLETE | MHHS-ART148/169 | T3-TE-0074 | SITAG | T3 |

Notes:
- 675: Action: 21/8 - Rework with Lee
- 677: Action: 21/8 - Rework with Lee
- 678: Action: 21/8 - Rework with Lee
- 679: Action: 21/8 - Rework with Lee
- 698: Action: 28/7: CH: Needs to be set-up as a reporting milestone. 31/7: Check with Cesar if has been approved so can be baselined

| ID | WBS | Task | Type | Duration | Start | Finish | Predecessors | Complete | Baseline start | Baseline finish | Baseline duration | Baseline 1 start | Baseline 1 finish | Constraint | Baseline cost | Responsible | Involved | Text9 | Update Version | MHHS Resource Name | MHHS Programme Phase | Sched Status | RAG | Artefact ID | Milestone ID | Text29 | Tier | Action |
| --- | --- | --- | --- | --- | --- | --- | --- | --- | --- | --- | --- | --- | --- | --- | --- | --- | --- | --- | --- | --- | --- | --- | --- | --- | --- | --- | --- | --- |
| 699 | 1.4.1.4.1.6.3 | **Other Preparation** |  | 87d | 2023-07-03 A | 2023-10-31 A |  | 100% | 2023-07-03 | 2023-10-31 | 87d | 2023-07-03 | 2023-09-22 |  | -0 | N/A | N/A | SIT | 5.0 | N/A | Systems Integration Testing (SIT) |  |  |  |  |  |  |  |
| 700 | 1.4.1.4.1.6.3.1 | Onboarding of Test Participants to Test Management Tool (Azure DevOps) |  | 60d | 2023-07-03 A | 2023-09-22 A | 683SF | 100% | 2023-07-03 | 2023-09-22 | 60d | 2023-07-03 | 2023-09-22 |  |  | SI Test | PP | SIT | 5.0 |  | Systems Integration Testing (SIT) | Complete | COMPLETE |  |  |  |  |  |
| 701 | 1.4.1.4.1.6.3.2 | Test Management Tool onboarding |  | 27d | 2023-09-25 A | 2023-10-31 A | 700 | 100% | 2023-09-25 | 2023-10-31 | 27d | 2023-07-03 | 2023-09-22 |  |  | PP | SI Test | SIT | 5.0 | Simon Berry | Systems Integration Testing (SIT) | Complete | COMPLETE |  |  |  |  |  |
| 702 | 1.4.1.4.1.6.4 | **SIT Component Integration Test Readiness Report** |  | 25d | 2023-10-02 A | 2023-11-03 A |  | 100% | 2023-10-02 | 2023-11-03 | 25d | 2023-10-02 | 2023-11-03 |  |  | N/A | N/A | SIT | 5.0 | N/A | Systems Integration Testing (SIT) |  |  |  |  |  |  |  |
| 703 | 1.4.1.4.1.6.4.1 | PP submit Test Readiness Report to Programme for assurance | milestone | 0d | 2023-10-25 A | 2023-10-25 A | 615FS+18d | 100% | 2023-10-25 | 2023-10-25 | 0d | 2023-10-20 | 2023-10-20 |  |  | PP | SI Test | SIT | 5.0 |  | Systems Integration Testing (SIT) | Complete | COMPLETE |  |  |  |  |  |
| 704 | 1.4.1.4.1.6.4.2 | SI assure Test Participants' Test Readiness Reports |  | 2d | 2023-10-26 A | 2023-10-27 A | 703 | 100% | 2023-10-26 | 2023-10-27 | 5d | 2023-10-23 | 2023-10-27 |  |  | SI Test | PP,IPA | SIT | 5.0 |  | Systems Integration Testing (SIT) | Complete | COMPLETE |  |  |  |  |  |
| 705 | 1.4.1.4.1.6.4.3 | SI develop Overarching SIT Component Integration Test Readiness Report |  | 20d | 2023-10-02 A | 2023-10-27 A | 704FF | 100% | 2023-10-02 | 2023-10-27 | 20d | 2023-10-02 | 2023-10-27 |  |  | SI Test |  | SIT | 5.0 |  | Systems Integration Testing (SIT) | Complete | COMPLETE |  |  |  |  |  |
| 706 | 1.4.1.4.1.6.4.4 | Artefact review (via TMAG) and updates |  | 5d | 2023-10-30 A | 2023-11-03 A | 705 | 100% | 2023-10-30 | 2023-11-03 | 5d | 2023-10-30 | 2023-11-03 |  |  | SI Test | PP,IPA | SIT | 5.0 |  | Systems Integration Testing (SIT) | Complete | COMPLETE |  |  |  |  |  |
| 707 | 1.4.1.4.1.6.5 | SIT Component Integration Testing 2 Preparation Complete (incl. approval of SI SIT Component Integration Test Readiness Report) | milestone | 0d | 2023-11-06 A | 2023-11-06 A | 701, 706FS+1d, 683, 311 | 100% | 2023-11-06 | 2023-11-06 | 0d | 2023-11-06 | 2023-11-06 |  |  | SI Test | PP,IPA | SIT | 5.11 |  | Systems Integration Testing (SIT) | Complete | COMPLETE | MHHS-ART071 | T2-TE-0300 | SITAG | T2 |  |
| 708 | 1.4.1.4.1.7 | **CIT Interval 3 Preparation** |  | 54d | 2023-10-03 A | 2023-12-15 A |  | 100% | 2023-10-03 | 2023-12-15 | 91d | 2022-11-16 | 2023-11-20 |  | -0 | N/A | N/A | SIT | 5.0 | N/A | Systems Integration Testing (SIT) |  |  |  |  |  |  |  |
| 709 | 1.4.1.4.1.7.1 | **PIT Test Completion Report (incl. evidence)** |  | 26d | 2023-10-13 A | 2023-11-17 A |  | 100% | 2023-10-13 | 2023-11-17 | 21d | 2023-10-13 | 2023-11-10 |  |  | N/A | N/A | SIT | 5.0 | N/A | Systems Integration Testing (SIT) |  |  |  |  |  |  |  |
| 710 | 1.4.1.4.1.7.1.1 | Submit draft PIT Test Completion Report (incl. evidence) and submit to Programme for assurance |  | 11d | 2023-10-13 A | 2023-10-27 A |  | 100% | 2023-10-13 | 2023-10-27 | 1d | 2023-10-13 | 2023-10-13 | must start on 2023-10-13 |  | PP | SI Test | SIT | 5.0 |  | Systems Integration Testing (SIT) | Complete | COMPLETE |  |  |  |  |  |
| 711 | 1.4.1.4.1.7.1.2 | Finalise PIT Test Completion Report (incl. evidence) |  | 5d | 2023-10-30 A | 2023-11-03 A | 710 | 100% | 2023-10-30 | 2023-11-03 | 15d | 2023-10-16 | 2023-11-03 |  |  | PP | SI Test | SIT | 5.0 |  | Systems Integration Testing (SIT) | Complete | COMPLETE |  |  |  |  |  |
| 712 | 1.4.1.4.1.7.1.3 | PP PIT Completion Report (excl. Migration/Reverse Migration) submitted to Programme for assurance CIT Interval 3 | milestone | 0d | 2023-11-03 A | 2023-11-03 A | 711, 79, 95 | 100% | 2023-11-03 | 2023-11-03 | 0d | 2023-11-03 | 2023-11-03 |  |  | PP | SI Test | SIT | 5.11 |  | Systems Integration Testing (SIT) | Complete | COMPLETE |  | T3-DB-0017 | SITAG | T3 |  |
| 713 | 1.4.1.4.1.7.1.4 | PP Final PIT Completion Reports assured by SI |  | 10d | 2023-11-06 A | 2023-11-17 A | 712 | 100% | 2023-11-06 | 2023-11-17 | 5d | 2023-11-06 | 2023-11-10 |  |  | SI Test | PP | SIT | 5.0 |  | Systems Integration Testing (SIT) | Complete | COMPLETE |  |  |  |  |  |
| 714 | 1.4.1.4.1.7.2 | **Environments (SIT A)** |  | 51d | 2023-10-06 A | 2023-12-15 A |  | 100% | 2023-10-06 | 2023-12-15 | 26d | 2022-11-16 | 2023-11-10 |  | -0 | N/A | N/A | SIT | 5.0 | N/A | Systems Integration Testing (SIT) |  |  |  |  |  |  |  |
| 715 | 1.4.1.4.1.7.2.1 | Programme Participants Ready to Start Connectivity Proving | milestone | 0d | 2023-10-06 A | 2023-10-06 A |  | 100% | 2023-10-06 | 2023-10-06 | 0d |  |  | start no earlier than 2023-10-06 |  | PP | PP.SI Test | SIT | 5.10 | Simon Berry | Systems Integration Testing (SIT) | Complete | COMPLETE |  |  |  |  |  |
| 716 | 1.4.1.4.1.7.2.2 | SIT Participants' SIT A environments ready to start connectivity proving CIT Interval 3 | milestone | 0d | 2023-10-06 A | 2023-10-06 A | 715 | 100% | 2023-10-06 | 2023-10-06 | 0d | 2023-10-06 | 2023-10-06 |  |  | PP | PP,SI Test | SIT | 5.10 | Simon Berry | Systems Integration Testing (SIT) | Complete | COMPLETE | MHHS-ART139 | T3-TE-0021 | SITAG | T3 | 30/8 - lee said date is 30/10 |
| 717 | 1.4.1.4.1.7.2.3 | Internal Connectivity Proving Phase |  | 10d | 2023-10-09 A | 2023-10-20 A | 715FS+1d | 100% | 2023-10-09 | 2023-10-20 | 10d |  |  |  |  | PP | PP,SI Test | SIT | 5.10 | Simon Berry | Systems Integration Testing (SIT) | Complete | COMPLETE |  |  |  |  |  |
| 718 | 1.4.1.4.1.7.2.4 | Internal Connectivity Proving Phase Complete | milestone | 0d | 2023-10-20 A | 2023-10-20 A | 717 | 100% | 2023-10-20 | 2023-10-20 | 0d |  |  |  |  | PP | PP,SI Test | SIT | 5.10 | Simon Berry | Systems Integration Testing (SIT) | Complete | COMPLETE |  |  |  |  |  |
| 719 | 1.4.1.4.1.7.2.5 | DIP Onboarding Activity (1. PKI Officers and Certificates, 2. Set-up Validation, 3. End Point Creation, 4. Controlled Smoke Test ) |  | 35d | 2023-10-30 A | 2023-12-15 A | 718FS+5d | 100% | 2023-10-30 | 2023-12-15 | 10d |  |  |  |  | PP | PP,DIP Provider | SIT | 5.10 | Simon Berry | Systems Integration Testing (SIT) | Complete | COMPLETE |  |  |  |  |  |
| 720 | 1.4.1.4.1.7.2.6 | DIP Onboarding Complete | milestone | 0d | 2023-12-15 A | 2023-12-15 A | 719 | 100% | 2023-12-15 | 2023-12-15 | 0d |  |  |  |  | PP | PP,DIP Provider | SIT | 5.10 | Simon Berry | Systems Integration Testing (SIT) | Complete | COMPLETE |  |  |  |  |  |
| 721 | 1.4.1.4.1.7.2.7 | PPs Register PKI Officers and Request PKI certificates Complete - Interval 3 | milestone | 0d | 2023-12-15 A | 2023-12-15 A | 720FF | 100% | 2023-12-15 | 2023-12-15 | 0d | 2023-10-02 | 2023-10-06 |  |  | PP | PP,DIP Provider | SIT | 5.13 | Simon Berry | Systems Integration Testing (SIT) | Complete | COMPLETE |  | T3-TE-0099 | SITAG | T3 |  |
| 722 | 1.4.1.4.1.7.2.8 | PP Code Deployment | milestone | 0d | 2023-11-10 A | 2023-11-10 A | 718FS+15d | 100% | 2023-11-10 | 2023-11-10 | 0d |  |  | start no earlier than 2023-10-20 |  | PP | PP | SIT | 5.10 | Simon Berry | Systems Integration Testing (SIT) | Complete | COMPLETE |  |  |  |  |  |

| ID | WBS | Task | Type | Duration | Start | Finish | Predecessors | Complete | Baseline start | Baseline finish | Baseline duration | Baseline 1 start | Baseline 1 finish | Constraint | Baseline cost | Responsible | Involved | Text9 | Update Version | MHHS Resource Name | MHHS Programme Phase | Sched Status | RAG | Artefact ID | Milestone ID | Text29 | Tier |
| --- | --- | --- | --- | --- | --- | --- | --- | --- | --- | --- | --- | --- | --- | --- | --- | --- | --- | --- | --- | --- | --- | --- | --- | --- | --- | --- | --- |
| 723 | 1.4.1.4.1.7.3 | **Test Data (SIT A) Interval 3** |  | 34d | 2023-10-03 A | 2023-11-17 A |  | 100% | 2023-10-03 | 2023-11-17 | 25d | 2023-10-02 | 2023-11-03 |  |  | N/A | N/A | SIT | 5.0 | N/A | Systems Integration Testing (SIT) |  |  |  |  |  |  |
| 724 | 1.4.1.4.1.7.3.1 | Run data allocation |  | 4d | 2023-10-03 A | 2023-10-06 A | 694SS | 100% | 2023-10-03 | 2023-10-06 | 5d | 2023-10-02 | 2023-10-06 |  |  | SI Test |  | SIT | 5.0 | Cesar Lopes | Systems Integration Testing (SIT) | Complete | COMPLETE |  |  |  |  |
| 725 | 1.4.1.4.1.7.3.2 | Cleanse and populate data post cut |  | 5d | 2023-10-09 A | 2023-10-13 A | 724 | 100% | 2023-10-09 | 2023-10-13 | 5d | 2023-10-09 | 2023-10-13 |  |  | SI Test |  | SIT | 5.0 | Cesar Lopes | Systems Integration Testing (SIT) | Complete | COMPLETE |  |  |  |  |
| 726 | 1.4.1.4.1.7.3.3 | Transmit data sets to PPs |  | 2d | 2023-10-16 A | 2023-10-17 A | 725 | 100% | 2023-10-16 | 2023-10-17 | 2d | 2023-10-16 | 2023-10-17 |  |  | SI Test |  | SIT | 5.0 | Cesar Lopes | Systems Integration Testing (SIT) | Complete | COMPLETE |  |  |  |  |
| 727 | 1.4.1.4.1.7.3.4 | PP - Load test data to test environments |  | 8d | 2023-10-18 A | 2023-10-27 A | 726 | 100% | 2023-10-18 | 2023-10-27 | 8d | 2023-10-18 | 2023-10-27 |  |  | PP |  | SIT | 5.0 | Cesar Lopes | Systems Integration Testing (SIT) | Complete | COMPLETE |  |  |  |  |
| 728 | 1.4.1.4.1.7.3.5 | PP Check data integrity on test environment |  | 15d | 2023-10-30 A | 2023-11-17 A | 727 | 100% | 2023-10-30 | 2023-11-17 | 5d | 2023-10-30 | 2023-11-03 |  |  | PP |  | SIT | 5.0 | Cesar Lopes | Systems Integration Testing (SIT) | Complete | COMPLETE |  |  |  |  |
| 729 | 1.4.1.4.1.7.3.6 | PP submit self-declaration to Programme to confirm loading & verification of test data | milestone | 0d | 2023-11-17 A | 2023-11-17 A | 728FF | 100% | 2023-11-17 | 2023-11-17 | 0d | 2023-11-03 | 2023-11-03 |  |  | PP | SI Test | SIT | 5.0 | Cesar Lopes | Systems Integration Testing (SIT) | Complete | COMPLETE |  |  |  |  |
| 730 | 1.4.1.4.1.7.3.7 | Test Data (SIT A) Interval 3 Complete | milestone | 0d | 2023-11-17 A | 2023-11-17 A | 729 | 100% | 2023-11-17 | 2023-11-17 | 0d |  |  |  |  | SI Test | PP | SIT | 5.13 | Cesar Lopes | Systems Integration Testing (SIT) | Complete | COMPLETE | MHHS-ART148/169 | T3-TE-0075 | SITAG | T3 |
| 731 | 1.4.1.4.1.7.4 | **Other Preparation** |  | 25d | 2023-10-16 A | 2023-11-17 A |  | 100% | 2023-10-16 | 2023-11-17 | 60d | 2023-07-17 | 2023-10-06 |  |  | N/A | N/A | SIT | 5.0 | N/A | Systems Integration Testing (SIT) |  |  |  |  |  |  |
| 732 | 1.4.1.4.1.7.4.1 | Onboarding of Test Participants to Test Management Tool (Azure DevOps) |  | 25d | 2023-10-16 A | 2023-11-17 A |  | 100% | 2023-10-16 | 2023-11-17 | 60d | 2023-07-17 | 2023-10-06 | start no earlier than 2023-10-16 |  | SI Test | PP | SIT | 5.0 | Simon Berry | Systems Integration Testing (SIT) | Complete | COMPLETE |  |  |  |  |
| 733 | 1.4.1.4.1.7.4.2 | Test Management Tool onboarding |  | 25d | 2023-10-16 A | 2023-11-17 A |  | 100% | 2023-10-16 | 2023-11-17 | 60d | 2023-07-17 | 2023-10-06 | start no earlier than 2023-10-16 |  | PP | SI Test | SIT | 5.0 | Simon Berry | Systems Integration Testing (SIT) | Complete | COMPLETE |  |  |  |  |
| 734 | 1.4.1.4.1.7.5 | **SIT Component Integration Test Readiness Report** |  | 25d | 2023-10-16 A | 2023-11-17 A |  | 100% | 2023-10-16 | 2023-11-17 | 25d | 2023-10-16 | 2023-11-17 |  |  | N/A | N/A | SIT | 5.0 | N/A | Systems Integration Testing (SIT) |  |  |  |  |  |  |
| 735 | 1.4.1.4.1.7.5.1 | PP submit Test Readiness Report to Programme for assurance | milestone | 0d | 2023-11-03 A | 2023-11-03 A | 619 | 100% | 2023-11-03 | 2023-11-03 | 0d | 2023-11-03 | 2023-11-03 |  |  | PP | SI Test | SIT | 5.0 |  | Systems Integration Testing (SIT) | Complete | COMPLETE |  |  |  |  |
| 736 | 1.4.1.4.1.7.5.2 | SI assure Test Participants' Test Readiness Reports |  | 5d | 2023-11-06 A | 2023-11-10 A | 735FF+5d | 100% | 2023-11-06 | 2023-11-10 | 5d | 2023-11-06 | 2023-11-10 |  |  | SI Test | PP,IPA | SIT | 5.0 |  | Systems Integration Testing (SIT) | Complete | COMPLETE |  |  |  |  |
| 737 | 1.4.1.4.1.7.5.3 | SI develop Overarching SIT Component Integration Test Readiness Report |  | 20d | 2023-10-16 A | 2023-11-10 A | 736FF | 100% | 2023-10-16 | 2023-11-10 | 20d | 2023-10-16 | 2023-11-10 |  |  | SI Test |  | SIT | 5.0 |  | Systems Integration Testing (SIT) | Complete | COMPLETE |  |  |  |  |
| 738 | 1.4.1.4.1.7.5.4 | Artefact review (via TMAG) and updates |  | 5d | 2023-11-13 A | 2023-11-17 A | 737 | 100% | 2023-11-13 | 2023-11-17 | 5d | 2023-11-13 | 2023-11-17 |  |  | SI Test | PP,IPA | SIT | 5.0 |  | Systems Integration Testing (SIT) | Complete | COMPLETE |  |  |  |  |
| 739 | 1.4.1.4.1.7.6 | SIT Component Integration Testing 3 Preparation Complete (incl. approval of SI SIT Component Integration Test Readiness Report) | milestone | 0d | 2023-11-20 A | 2023-11-20 A | 738FS+1d, 712, 716, 735, 733, 730, 329 | 100% | 2023-11-20 | 2023-11-20 | 0d | 2023-11-20 | 2023-11-20 |  |  | SI Test | PP,IPA | SIT | 5.12 |  | Systems Integration Testing (SIT) | Complete | COMPLETE | MHHS-ART071 | T2-TE-0350 | SITAG | T2 |
| 740 | 1.4.1.4.1.8 | **CIT Interval 4 Preparation** |  | 36d | 2023-10-16 A | 2023-12-04 A |  | 100% | 2023-10-16 | 2023-12-04 | 36d | 2022-11-16 | 2023-12-04 |  | -0 | N/A | N/A | SIT | 5.0 | N/A | Systems Integration Testing (SIT) |  |  |  |  |  |  |
| 741 | 1.4.1.4.1.8.1 | **PIT Test Completion Report (incl. evidence)** |  | 21d | 2023-10-27 A | 2023-11-24 A |  | 100% | 2023-10-27 | 2023-11-24 | 21d | 2023-10-27 | 2023-11-24 |  |  | N/A | N/A | SIT | 5.0 | N/A | Systems Integration Testing (SIT) |  |  |  |  |  |  |
| 742 | 1.4.1.4.1.8.1.1 | Submit draft PIT Test Completion Report (incl. evidence) and submit to Programme for assurance |  | 1d | 2023-10-27 A | 2023-10-27 A |  | 100% | 2023-10-27 | 2023-10-27 | 1d | 2023-10-27 | 2023-10-27 | must start on 2023-10-27 |  | PP | SI Test | SIT | 5.0 |  | Systems Integration Testing (SIT) | Complete | COMPLETE |  |  |  |  |
| 743 | 1.4.1.4.1.8.1.2 | Finalise PIT Test Completion Report (incl. evidence) |  | 15d | 2023-10-30 A | 2023-11-17 A | 742 | 100% | 2023-10-30 | 2023-11-17 | 15d | 2023-10-30 | 2023-11-17 |  |  | PP | SI Test | SIT | 5.0 |  | Systems Integration Testing (SIT) | Complete | COMPLETE |  |  |  |  |
| 744 | 1.4.1.4.1.8.1.3 | PP PIT Completion Report (excl. Migration/Reverse Migration) submitted to Programme for assurance CIT Interval 4 | milestone | 0d | 2023-11-17 A | 2023-11-17 A | 743, 79, 95 | 100% | 2023-11-17 | 2023-11-17 | 0d | 2023-11-17 | 2023-11-17 |  |  | PP | SI Test | SIT | 5.13 |  | Systems Integration Testing (SIT) | Complete | COMPLETE |  | T3-DB-0019 | SITAG | T3 |
| 745 | 1.4.1.4.1.8.1.4 | PP Final PIT Completion Reports assured by SI |  | 5d | 2023-11-20 A | 2023-11-24 A | 744 | 100% | 2023-11-20 | 2023-11-24 | 5d | 2023-11-20 | 2023-11-24 |  |  | SI Test | PP | SIT | 5.0 |  | Systems Integration Testing (SIT) | Complete | COMPLETE |  |  |  |  |
| 746 | 1.4.1.4.1.8.2 | **Environments (SIT A)** |  | 25d | 2023-10-23 A | 2023-11-24 A |  | 100% | 2023-10-23 | 2023-11-24 | 25d | 2022-11-16 | 2023-11-24 |  | -0 | N/A | N/A | SIT | 5.0 | N/A | Systems Integration Testing (SIT) |  |  |  |  |  |  |
| 747 | 1.4.1.4.1.8.2.1 | Programme Participants Ready to Start Connectivity Proving | milestone | 0d | 2023-10-23 A | 2023-10-23 A |  | 100% | 2023-10-23 | 2023-10-23 | 0d |  |  | start no earlier than 2023-10-23 |  | PP |  | SIT | 5.10 | Simon Berry | Systems Integration Testing (SIT) | Complete | COMPLETE |  |  |  |  |
| 748 | 1.4.1.4.1.8.2.2 | SIT Participants' SIT A environments ready to start connectivity proving CIT Interval 4 | milestone | 0d | 2023-10-23 A | 2023-10-23 A | 747 | 100% | 2023-10-23 | 2023-10-23 | 0d | 2023-10-20 | 2023-10-20 |  |  | PP | PP,IPA | SIT | 5.10 | Simon Berry | Systems Integration Testing (SIT) | Complete | COMPLETE | MHHS-ART139 | T3-TE-0022 | SITAG | T3 |
| 749 | 1.4.1.4.1.8.2.3 | Internal Connectivity Proving Phase |  | 10d | 2023-10-23 A | 2023-11-03 A | 748 | 100% | 2023-10-23 | 2023-11-03 | 10d |  |  |  |  | PP |  | SIT | 5.10 | Simon Berry | Systems Integration Testing (SIT) | Complete | COMPLETE |  |  |  |  |
| 750 | 1.4.1.4.1.8.2.4 | Internal Connectivity Proving Phase Complete | milestone | 0d | 2023-11-03 A | 2023-11-03 A | 749 | 100% | 2023-11-03 | 2023-11-03 | 0d |  |  |  |  | PP |  | SIT | 5.10 | Simon Berry | Systems Integration Testing (SIT) | Complete | COMPLETE |  |  |  |  |
| 751 | 1.4.1.4.1.8.2.5 | DIP Onboarding Activity (1. PKI Officers and Certificates, 2. Set-up Validation, 3. End Point Creation, 4. Controlled Smoke Test ) |  | 10d | 2023-11-13 A | 2023-11-24 A | 750FS+5d | 100% | 2023-11-13 | 2023-11-24 | 10d |  |  |  |  | PP |  | SIT | 5.10 | Simon Berry | Systems Integration Testing (SIT) | Complete | COMPLETE |  |  |  |  |
| 752 | 1.4.1.4.1.8.2.6 | DIP Onboarding Complete | milestone | 0d | 2023-11-24 A | 2023-11-24 A | 751 | 100% | 2023-11-24 | 2023-11-24 | 0d |  |  |  |  | PP |  | SIT | 5.10 | Simon Berry | Systems Integration Testing (SIT) | Complete | COMPLETE |  |  |  |  |
| 753 | 1.4.1.4.1.8.2.7 | PPs register PKI Officers and Request PKI Certificates Complete - Interval 4 | milestone | 0d | 2023-11-24 A | 2023-11-24 A | 752 | 100% | 2023-11-24 | 2023-11-24 | 0d |  |  |  |  | PP | DIP Provider | SIT | 5.16 | Simon Berry | Systems Integration Testing (SIT) | Complete | COMPLETE |  | T3-TE-0100 | SITAG | T3 |
| 754 | 1.4.1.4.1.8.2.8 | PP Code Deployment | milestone | 0d | 2023-11-17 A | 2023-11-17 A |  | 100% | 2023-11-17 | 2023-11-17 | 0d |  |  | start no earlier than 2023-11-17 |  | PP |  | SIT | 5.10 | Simon Berry | Systems Integration Testing (SIT) | Complete | COMPLETE |  |  |  |  |

Notes:
- 730: Action: 28/7: CH: Needs to be set-up as a reporting milestone. 31/7: Check with Cesar if has been approved so can be baselined

| ID | WBS | Task | Type | Duration | Start | Finish | Predecessors | Complete | Baseline start | Baseline finish | Baseline duration | Baseline 1 start | Baseline 1 finish | Constraint | Baseline cost | Responsible | Involved | Text9 | Update Version | MHHS Resource Name | MHHS Programme Phase | Sched Status | RAG | Artefact ID | Milestone ID | Text29 | Tier |
| --- | --- | --- | --- | --- | --- | --- | --- | --- | --- | --- | --- | --- | --- | --- | --- | --- | --- | --- | --- | --- | --- | --- | --- | --- | --- | --- | --- |
| 755 | 1.4.1.4.1.8.3 | **Test Data (SIT A) Interval 4** |  | 30d | 2023-10-23 A | 2023-12-01 A |  | 100% | 2023-10-23 | 2023-12-01 | 25d | 2023-10-16 | 2023-11-17 |  |  | N/A | N/A | SIT | 5.0 | N/A | Systems Integration Testing (SIT) |  |  |  |  |  |  |
| 756 | 1.4.1.4.1.8.3.1 | Run data allocation |  | 5d | 2023-10-23 A | 2023-10-27 A | 725FS+5d | 100% | 2023-10-23 | 2023-10-27 | 5d | 2023-10-16 | 2023-10-20 |  |  | SI Test |  | SIT | 5.0 | Cesar Lopes | Systems Integration Testing (SIT) | Complete | COMPLETE |  |  |  |  |
| 757 | 1.4.1.4.1.8.3.2 | Cleanse and populate data post cut |  | 2d | 2023-10-30 A | 2023-10-31 A | 756 | 100% | 2023-10-30 | 2023-10-31 | 5d | 2023-10-23 | 2023-10-27 |  |  | SI Test |  | SIT | 5.0 | Cesar Lopes | Systems Integration Testing (SIT) | Complete | COMPLETE |  |  |  |  |
| 758 | 1.4.1.4.1.8.3.3 | Transmit data sets to PPs |  | 5d | 2023-11-01 A | 2023-11-07 A | 757 | 100% | 2023-11-01 | 2023-11-07 | 2d | 2023-10-30 | 2023-10-31 |  |  | SI Test |  | SIT | 5.0 | Cesar Lopes | Systems Integration Testing (SIT) | Complete | COMPLETE |  |  |  |  |
| 759 | 1.4.1.4.1.8.3.4 | PP - Load test data to test environments |  | 5d | 2023-11-08 A | 2023-11-14 A | 758 | 100% | 2023-11-08 | 2023-11-14 | 8d | 2023-11-01 | 2023-11-10 |  |  | PP |  | SIT | 5.0 | Cesar Lopes | Systems Integration Testing (SIT) | Complete | COMPLETE |  |  |  |  |
| 760 | 1.4.1.4.1.8.3.5 | PP Check data integrity on test environment |  | 13d | 2023-11-15 A | 2023-12-01 A | 759 | 100% | 2023-11-15 | 2023-12-01 | 5d | 2023-11-13 | 2023-11-17 |  |  | PP |  | SIT | 5.0 | Richard Puddephatt | Systems Integration Testing (SIT) | Complete | COMPLETE |  |  |  |  |
| 761 | 1.4.1.4.1.8.3.6 | PP submit self-declaration to Programme to confirm loading & verification of test data | milestone | 0d | 2023-12-01 A | 2023-12-01 A | 760FF | 100% | 2023-12-01 | 2023-12-01 | 0d | 2023-11-17 | 2023-11-17 |  |  | PP | SI Test | SIT | 5.0 | Richard Puddephatt | Systems Integration Testing (SIT) | Complete | COMPLETE |  |  |  |  |
| 762 | 1.4.1.4.1.8.3.7 | Test Data (SIT A) Interval 4 Complete | milestone | 0d | 2023-12-01 A | 2023-12-01 A | 761 | 100% | 2023-12-01 | 2023-12-01 | 0d |  |  |  |  | SI Test | PP | SIT | 5.13 | Richard Puddephatt | Systems Integration Testing (SIT) | Complete | COMPLETE | MHHS-ART148/169 | T3-TE-0076 | SITAG | T3 |
| 763 | 1.4.1.4.1.8.4 | **Other Preparation** |  | 25d | 2023-10-30 A | 2023-12-01 A |  | 100% | 2023-10-30 | 2023-12-01 | 25d | 2023-07-31 | 2023-10-20 |  | -0 | N/A | N/A | SIT | 5.0 | N/A | Systems Integration Testing (SIT) |  |  |  |  |  |  |
| 764 | 1.4.1.4.1.8.4.1 | Onboarding of Test Participants to Test Management Tool (Azure DevOps) |  | 25d | 2023-10-30 A | 2023-12-01 A |  | 100% | 2023-10-30 | 2023-12-01 | 25d | 2023-07-31 | 2023-10-20 | start no earlier than 2023-10-30 |  | SI Test | PP | SIT | 5.0 | Simon Berry | Systems Integration Testing (SIT) | Complete | COMPLETE |  |  |  |  |
| 765 | 1.4.1.4.1.8.4.2 | Test Management Tool onboarding |  | 25d | 2023-10-30 A | 2023-12-01 A |  | 100% | 2023-10-30 | 2023-12-01 | 25d | 2023-07-31 | 2023-10-20 | start no earlier than 2023-10-30 |  | PP | SI Test | SIT | 5.0 | Simon Berry | Systems Integration Testing (SIT) | Complete | COMPLETE |  |  |  |  |
| 766 | 1.4.1.4.1.8.5 | **SIT Component Integration Test Readiness Report** |  | 27d | 2023-10-16 A | 2023-11-21 A |  | 100% | 2023-10-16 | 2023-11-21 | 25d | 2023-10-30 | 2023-12-01 |  |  | N/A | N/A | SIT | 5.0 | N/A | Systems Integration Testing (SIT) |  |  |  |  |  |  |
| 767 | 1.4.1.4.1.8.5.1 | PP submit Test Readiness Report to Programme for assurance | milestone | 0d | 2023-11-03 A | 2023-11-03 A | 619 | 100% | 2023-11-03 | 2023-11-03 | 0d | 2023-11-17 | 2023-11-17 |  |  | PP | SI Test | SIT | 5.0 |  | Systems Integration Testing (SIT) | Complete | COMPLETE |  |  |  |  |
| 768 | 1.4.1.4.1.8.5.2 | SI assure Test Participants' Test Readiness Reports |  | 5d | 2023-11-06 A | 2023-11-10 A | 767FF+5d | 100% | 2023-11-06 | 2023-11-10 | 5d | 2023-11-20 | 2023-11-24 |  |  | SI Test | PP,IPA | SIT | 5.0 |  | Systems Integration Testing (SIT) | Complete | COMPLETE |  |  |  |  |
| 769 | 1.4.1.4.1.8.5.3 | SI develop Overarching SIT Component Integration Test Readiness Report |  | 20d | 2023-10-16 A | 2023-11-10 A | 768FF | 100% | 2023-10-16 | 2023-11-10 | 20d | 2023-10-30 | 2023-11-24 |  |  | SI Test |  | SIT | 5.0 |  | Systems Integration Testing (SIT) | Complete | COMPLETE |  |  |  |  |
| 770 | 1.4.1.4.1.8.5.4 | Artefact review (via SITAG) and updates |  | 7d | 2023-11-13 A | 2023-11-21 A | 769 | 100% | 2023-11-13 | 2023-11-21 | 5d | 2023-11-27 | 2023-12-01 |  |  | SI Test | PP,IPA | SIT | 5.0 |  | Systems Integration Testing (SIT) | Complete | COMPLETE |  |  |  |  |
| 771 | 1.4.1.4.1.8.6 | SIT Component Integration Testing 4 Preparation Complete (incl. approval of SI SIT Component Integration Test Readiness Report) | milestone | 0d | 2023-12-04 A | 2023-12-04 A | 770FS+2d, 744, 748, 767, 762, 346FS+1d | 100% | 2023-12-04 | 2023-12-04 | 0d | 2023-12-04 | 2023-12-04 |  |  | SI Test | PP,IPA | SIT | 5.13 |  | Systems Integration Testing (SIT) | Complete | COMPLETE | MHHS-ART071 | T2-TE-0400 | SITAG | T2 |
| 772 | 1.4.1.4.1.9 | **CIT Interval 5 Preparation** |  | 53d | 2023-11-01 A | 2024-01-12 A |  | 100% | 2023-11-01 | 2024-01-12 | 55d | 2022-11-16 | 2024-01-08 |  | -0 | N/A | N/A | SIT | 5.0 | N/A | Systems Integration Testing (SIT) |  |  |  |  |  |  |
| 773 | 1.4.1.4.1.9.1 | **PIT Test Completion Report (incl. evidence)** |  | 21d | 2023-11-17 A | 2023-12-15 A |  | 100% | 2023-11-17 | 2023-12-15 | 21d | 2023-11-17 | 2023-12-15 |  |  | N/A | N/A | SIT | 5.0 | N/A | Systems Integration Testing (SIT) |  |  |  |  |  |  |
| 774 | 1.4.1.4.1.9.1.1 | Submit draft PIT Test Completion Report (incl. evidence) and submit to Programme for assurance |  | 1d | 2023-11-17 A | 2023-11-17 A |  | 100% | 2023-11-17 | 2023-11-17 | 1d | 2023-11-17 | 2023-11-17 | must start on 2023-11-17 |  | PP | SI Test | SIT | 5.0 | Lee Cox | Systems Integration Testing (SIT) | Complete | COMPLETE |  |  |  |  |
| 775 | 1.4.1.4.1.9.1.2 | Finalise PIT Test Completion Report (incl. evidence) |  | 15d | 2023-11-20 A | 2023-12-08 A | 774 | 100% | 2023-11-20 | 2023-12-08 | 15d | 2023-11-20 | 2023-12-08 |  |  | PP | SI Test | SIT | 5.0 | Lee Cox | Systems Integration Testing (SIT) | Complete | COMPLETE |  |  |  |  |
| 776 | 1.4.1.4.1.9.1.3 | PP PIT Completion Report (excl. Migration/Reverse Migration) submitted to Programme for assurance CIT Interval 5 | milestone | 0d | 2023-12-08 A | 2023-12-08 A | 775, 79, 95 | 100% | 2023-12-08 | 2023-12-08 | 0d | 2023-12-08 | 2023-12-08 |  |  | PP | SI Test | SIT | 5.14 | Lee Cox | Systems Integration Testing (SIT) | Complete | COMPLETE |  | T3-DB-0021 | SITAG | T3 |
| 777 | 1.4.1.4.1.9.1.4 | PP Final PIT Completion Reports assured by SI |  | 5d | 2023-12-11 A | 2023-12-15 A | 776 | 100% | 2023-12-11 | 2023-12-15 | 5d | 2023-12-11 | 2023-12-15 |  |  | SI Test | PP | SIT | 5.0 | Lee Cox | Systems Integration Testing (SIT) | Complete | COMPLETE |  |  |  |  |
| 778 | 1.4.1.4.1.9.2 | **Environments (SIT A)** |  | 21d | 2023-11-10 A | 2023-12-08 A |  | 100% | 2023-11-10 | 2023-12-08 | 21d | 2022-11-16 | 2023-12-15 |  | -0 | N/A | N/A | SIT | 5.0 | N/A | Systems Integration Testing (SIT) |  |  |  |  |  |  |
| 779 | 1.4.1.4.1.9.2.1 | Programme Participants Ready to Start Connectivity Proving | milestone | 0d | 2023-11-10 A | 2023-11-10 A |  | 100% | 2023-11-10 | 2023-11-10 | 0d |  |  | start no earlier than 2023-11-10 |  | PP |  | SIT | 5.10 | Simon Berry | Systems Integration Testing (SIT) | Complete | COMPLETE |  |  |  |  |
| 780 | 1.4.1.4.1.9.2.2 | SIT Participants' SIT A environments ready to start connectivity proving CIT Interval 5 | milestone | 0d | 2023-11-10 A | 2023-11-10 A | 779 | 100% | 2023-11-10 | 2023-11-10 | 0d | 2023-11-10 | 2023-11-10 |  |  | PP | PP,IPA | SIT | 5.6 | Simon Berry | Systems Integration Testing (SIT) | Complete | COMPLETE | MHHS-ART139 | T3-TE-0023 | SITAG | T3 |
| 781 | 1.4.1.4.1.9.2.3 | Internal Connectivity Proving Phase |  | 10d | 2023-11-13 A | 2023-11-24 A | 779FS+1d | 100% | 2023-11-13 | 2023-11-24 | 10d |  |  |  |  | PP |  | SIT | 5.10 | Simon Berry | Systems Integration Testing (SIT) | Complete | COMPLETE |  |  |  |  |
| 782 | 1.4.1.4.1.9.2.4 | Internal Connectivity Proving Phase Complete | milestone | 0d | 2023-11-24 A | 2023-11-24 A | 781 | 100% | 2023-11-24 | 2023-11-24 | 0d |  |  |  |  | PP |  | SIT | 5.10 | Simon Berry | Systems Integration Testing (SIT) | Complete | COMPLETE |  |  |  |  |
| 783 | 1.4.1.4.1.9.2.5 | DIP Onboarding Activity (1. PKI Officers and Certificates, 2. Set-up Validation, 3. End Point Creation, 4. Controlled Smoke Test ) |  | 10d | 2023-11-27 A | 2023-12-08 A | 782 | 100% | 2023-11-27 | 2023-12-08 | 10d |  |  |  |  | PP |  | SIT | 5.10 | Simon Berry | Systems Integration Testing (SIT) | Complete | COMPLETE |  |  |  |  |
| 784 | 1.4.1.4.1.9.2.6 | DIP Onboarding Complete | milestone | 0d | 2023-12-08 A | 2023-12-08 A | 783 | 100% | 2023-12-08 | 2023-12-08 | 0d |  |  |  |  | PP |  | SIT | 5.10 | Simon Berry | Systems Integration Testing (SIT) | Complete | COMPLETE |  |  |  |  |
| 785 | 1.4.1.4.1.9.2.7 | PPs register PKI Officers and Request PKI Certificates Complete - Interval 5 | milestone | 0d | 2023-12-08 A | 2023-12-08 A | 784 | 100% | 2023-12-08 | 2023-12-08 | 0d | 2023-11-06 | 2023-11-10 |  |  | PP | DIP Provider | SIT | 5.17 | Simon Berry | Systems Integration Testing (SIT) | Complete | COMPLETE |  | T3-TE-0101 | SITAG | T3 |
| 786 | 1.4.1.4.1.9.2.8 | PP Code Deployment | milestone | 0d | 2023-12-08 A | 2023-12-08 A | 785 | 100% | 2023-12-08 | 2023-12-08 | 0d |  |  | start no earlier than 2023-10-20 |  | PP |  | SIT | 5.10 | Simon Berry | Systems Integration Testing (SIT) | Complete | COMPLETE |  |  |  |  |

| ID | WBS | Task | Type | Duration | Start | Finish | Predecessors | Complete | Baseline start | Baseline finish | Baseline duration | Baseline 1 start | Baseline 1 finish | Constraint | Baseline cost | Responsible | Involved | Text9 | Update Version | MHHS Resource Name | MHHS Programme Phase | Sched Status | RAG | Artefact ID | Milestone ID | Text29 | Tier |
| --- | --- | --- | --- | --- | --- | --- | --- | --- | --- | --- | --- | --- | --- | --- | --- | --- | --- | --- | --- | --- | --- | --- | --- | --- | --- | --- | --- |
| 787 | 1.4.1.4.1.9.3 | **Test Data (SIT A) Interval 5** |  | 33d | 2023-11-01 A | 2023-12-15 A |  | 100% | 2023-11-01 | 2023-12-15 | 30d | 2023-10-30 | 2023-12-08 |  |  | N/A | N/A | SIT | 5.0 | N/A | Systems Integration Testing (SIT) |  |  |  |  |  |  |
| 788 | 1.4.1.4.1.9.3.1 | Run data allocation |  | 5d | 2023-11-01 A | 2023-11-07 A | 758SS | 100% | 2023-11-01 | 2023-11-07 | 10d | 2023-10-30 | 2023-11-10 |  |  | SI Test |  | SIT | 5.0 | Cesar Lopes | Systems Integration Testing (SIT) | Complete | COMPLETE |  |  |  |  |
| 789 | 1.4.1.4.1.9.3.2 | Cleanse and populate data post cut |  | 8d | 2023-11-08 A | 2023-11-17 A | 788 | 100% | 2023-11-08 | 2023-11-17 | 5d | 2023-11-13 | 2023-11-17 |  |  | SI Test |  | SIT | 5.0 | Cesar Lopes | Systems Integration Testing (SIT) | Complete | COMPLETE |  |  |  |  |
| 790 | 1.4.1.4.1.9.3.3 | Transmit data sets to PPs |  | 2d | 2023-11-20 A | 2023-11-21 A | 789 | 100% | 2023-11-20 | 2023-11-21 | 2d | 2023-11-20 | 2023-11-21 |  |  | SI Test |  | SIT | 5.0 | Cesar Lopes | Systems Integration Testing (SIT) | Complete | COMPLETE |  |  |  |  |
| 791 | 1.4.1.4.1.9.3.4 | PP - Load test data to test environments |  | 8d | 2023-11-22 A | 2023-12-01 A | 790 | 100% | 2023-11-22 | 2023-12-01 | 8d | 2023-11-22 | 2023-12-01 |  |  | PP |  | SIT | 5.0 | Richard Puddephatt | Systems Integration Testing (SIT) | Complete | COMPLETE |  |  |  |  |
| 792 | 1.4.1.4.1.9.3.5 | PP Check data integrity on test environment |  | 10d | 2023-12-04 A | 2023-12-15 A | 791 | 100% | 2023-12-04 | 2023-12-15 | 5d | 2023-12-04 | 2023-12-08 |  |  | PP |  | SIT | 5.0 | Richard Puddephatt | Systems Integration Testing (SIT) | Complete | COMPLETE |  |  |  |  |
| 793 | 1.4.1.4.1.9.3.6 | PP submit self-declaration to Programme to confirm loading & verification of test data | milestone | 0d | 2023-12-15 A | 2023-12-15 A | 792FF | 100% | 2023-12-15 | 2023-12-15 | 0d | 2023-12-08 | 2023-12-08 |  |  | PP | SI Test | SIT | 5.0 | Richard Puddephatt | Systems Integration Testing (SIT) | Complete | COMPLETE |  |  |  |  |
| 794 | 1.4.1.4.1.9.3.7 | Test Data (SIT A) Interval 5 Complete | milestone | 0d | 2023-12-15 A | 2023-12-15 A | 793 | 100% | 2023-12-15 | 2023-12-15 | 0d |  |  |  |  | SI Test | PP | SIT | 5.14 | Richard Puddephatt | Systems Integration Testing (SIT) | Complete | COMPLETE | MHHS-ART148/169 | T3-TE-0077 | SITAG | T3 |
| 795 | 1.4.1.4.1.9.4 | **Other Preparation** |  | 40d | 2023-11-20 A | 2024-01-12 A |  | 100% | 2023-11-20 | 2024-01-12 | 40d | 2023-08-21 | 2023-11-10 |  | -0 | N/A | N/A | SIT | 5.0 | N/A | Systems Integration Testing (SIT) |  |  |  |  |  |  |
| 796 | 1.4.1.4.1.9.4.1 | Onboarding of Test Participants to Test Management Tool (Azure DevOps) |  | 40d | 2023-11-20 A | 2024-01-12 A |  | 100% | 2023-11-20 | 2024-01-12 | 40d | 2023-08-21 | 2023-11-10 | start no earlier than 2023-11-20 |  | SI Test | PP | SIT | 5.0 | Simon Berry | Systems Integration Testing (SIT) | Complete | COMPLETE |  |  |  |  |
| 797 | 1.4.1.4.1.9.4.2 | Test Management Tool onboarding |  | 36d | 2023-11-20 A | 2024-01-08 A |  | 100% | 2023-11-20 | 2024-01-08 | 36d | 2023-08-21 | 2023-11-10 | start no earlier than 2023-11-20 |  | PP | SI Test | SIT | 5.0 | Simon Berry | Systems Integration Testing (SIT) | Complete | COMPLETE |  |  |  |  |
| 798 | 1.4.1.4.1.9.5 | **SIT Component Integration Test Readiness Report** |  | 35d | 2023-11-20 A | 2024-01-05 A |  | 100% | 2023-11-20 | 2024-01-05 | 35d | 2023-11-20 | 2024-01-05 |  |  | N/A | N/A | SIT | 5.0 | N/A | Systems Integration Testing (SIT) |  |  |  |  |  |  |
| 799 | 1.4.1.4.1.9.5.1 | PP submit Test Readiness Report to Programme for assurance | milestone | 0d | 2023-12-08 A | 2023-12-08 A | 623 | 100% | 2023-12-08 | 2023-12-08 | 0d | 2023-12-08 | 2023-12-08 |  |  | PP | SI Test | SIT | 5.0 | Lee Cox | Systems Integration Testing (SIT) | Complete | COMPLETE |  |  |  |  |
| 800 | 1.4.1.4.1.9.5.2 | SI assure Test Participants' Test Readiness Reports |  | 5d | 2023-12-11 A | 2023-12-15 A | 799FF+5d | 100% | 2023-12-11 | 2023-12-15 | 5d | 2023-12-11 | 2023-12-15 |  |  | SI Test | PP,IPA | SIT | 5.0 | Lee Cox | Systems Integration Testing (SIT) | Complete | COMPLETE |  |  |  |  |
| 801 | 1.4.1.4.1.9.5.3 | SI develop Overarching SIT Component Integration Test Readiness Report |  | 20d | 2023-11-20 A | 2023-12-15 A | 800FF | 100% | 2023-11-20 | 2023-12-15 | 20d | 2023-11-20 | 2023-12-15 |  |  | SI Test |  | SIT | 5.0 | Lee Cox | Systems Integration Testing (SIT) | Complete | COMPLETE |  |  |  |  |
| 802 | 1.4.1.4.1.9.5.4 | Artefact review (via SITAG) and updates |  | 15d | 2023-12-18 A | 2024-01-05 A | 801 | 100% | 2023-12-18 | 2024-01-05 | 15d | 2023-12-18 | 2024-01-05 |  |  | SI Test | PP,IPA | SIT | 5.0 | Lee Cox | Systems Integration Testing (SIT) | Complete | COMPLETE |  |  |  |  |
| 803 | 1.4.1.4.1.9.6 | SIT Component Integration Testing 5 Preparation Complete (incl. approval of SI SIT Component Integration Test Readiness Report) | milestone | 0d | 2024-01-08 A | 2024-01-08 A | 802FS+1d, 776, 780, 797, 799, 794, 449, 432 | 100% | 2024-01-08 | 2024-01-08 | 0d | 2024-01-08 | 2024-01-08 |  |  | SI Test | PP,IPA | SIT | 5.15 |  | Systems Integration Testing (SIT) | Complete | COMPLETE | MHHS-ART071 | T2-TE-0450 | SITAG | T2 |
| 804 | 1.4.1.4.1.10 | **CIT Interval 6 Preparation** |  | 45d | 2023-11-20 A | 2024-01-19 A |  | 100% | 2023-11-20 | 2024-01-19 | 46d | 2022-11-16 | 2024-01-22 |  | -0 | N/A | N/A | SIT | 5.0 | N/A | Systems Integration Testing (SIT) |  |  |  |  |  |  |
| 805 | 1.4.1.4.1.10.1 | **PIT Test Completion Report (incl. evidence)** |  | 31d | 2023-12-01 A | 2024-01-12 A |  | 100% | 2023-12-01 | 2024-01-12 | 31d | 2023-12-01 | 2024-01-12 |  |  | N/A | N/A | SIT | 5.0 | N/A | Systems Integration Testing (SIT) |  |  |  |  |  |  |
| 806 | 1.4.1.4.1.10.1.1 | Submit draft PIT Test Completion Report (incl. evidence) and submit to Programme for assurance |  | 1d | 2023-12-01 A | 2023-12-01 A |  | 100% | 2023-12-01 | 2023-12-01 | 1d | 2023-12-01 | 2023-12-01 | must start on 2023-12-01 |  | PP | SI Test | SIT | 5.0 |  | Systems Integration Testing (SIT) | Complete | COMPLETE |  |  |  |  |
| 807 | 1.4.1.4.1.10.1.2 | Finalise PIT Test Completion Report (incl. evidence) |  | 25d | 2023-12-04 A | 2024-01-05 A | 806 | 100% | 2023-12-04 | 2024-01-05 | 25d | 2023-12-04 | 2024-01-05 |  |  | PP | SI Test | SIT | 5.0 |  | Systems Integration Testing (SIT) | Complete | COMPLETE |  |  |  |  |
| 808 | 1.4.1.4.1.10.1.3 | PP PIT Completion Report (excl. Migration/Reverse Migration) submitted to Programme for assurance CIT Interval 6 | milestone | 0d | 2024-01-05 A | 2024-01-05 A | 807, 79, 95, 268, 273, 276 | 100% | 2024-01-05 | 2024-01-05 | 0d | 2024-01-05 | 2024-01-05 |  |  | PP | SI Test | SIT | 5.19 |  | Systems Integration Testing (SIT) | Complete | COMPLETE |  | T3-DB-0023 | SITAG | T3 |
| 809 | 1.4.1.4.1.10.1.4 | PP Final PIT Completion Reports assured by SI |  | 5d | 2024-01-08 A | 2024-01-12 A | 808 | 100% | 2024-01-08 | 2024-01-12 | 5d | 2024-01-08 | 2024-01-12 |  |  | SI Test | PP | SIT | 5.19 |  | Systems Integration Testing (SIT) | Complete | COMPLETE |  |  |  |  |
| 810 | 1.4.1.4.1.10.2 | **Environments (SIT A)** |  | 30d | 2023-11-24 A | 2024-01-05 A |  | 100% | 2023-11-24 | 2024-01-05 | 30d | 2022-11-16 | 2024-01-05 |  | -0 | N/A | N/A | SIT | 5.0 | N/A | Systems Integration Testing (SIT) |  |  |  |  |  |  |
| 811 | 1.4.1.4.1.10.2.1 | Programme Participants Ready to Start Connectivity Proving | milestone | 0d | 2023-11-24 A | 2023-11-24 A |  | 100% | 2023-11-24 | 2023-11-24 | 0d |  |  | start no earlier than 2023-11-24 |  | PP |  | SIT | 5.10 | Simon Berry | Systems Integration Testing (SIT) | Complete | COMPLETE |  |  |  |  |
| 812 | 1.4.1.4.1.10.2.2 | SIT Participants' SIT A environments ready to start connectivity proving CIT Interval 6 | milestone | 0d | 2023-11-24 A | 2023-11-24 A | 811 | 100% | 2023-11-24 | 2023-11-24 | 0d | 2023-11-24 | 2023-11-24 |  |  | PP | PP,IPA | SIT | 5.6 | Simon Berry | Systems Integration Testing (SIT) | Complete | COMPLETE | MHHS-ART139 | T3-TE-0024 | SITAG | T3 |
| 813 | 1.4.1.4.1.10.2.3 | Internal Connectivity Proving Phase |  | 10d | 2023-11-27 A | 2023-12-08 A | 812FS+1d | 100% | 2023-11-27 | 2023-12-08 | 10d |  |  |  |  | PP |  | SIT | 5.10 | Simon Berry | Systems Integration Testing (SIT) | Complete | COMPLETE |  |  |  |  |
| 814 | 1.4.1.4.1.10.2.4 | Internal Connectivity Proving Phase Complete | milestone | 0d | 2023-12-08 A | 2023-12-08 A | 813 | 100% | 2023-12-08 | 2023-12-08 | 0d |  |  |  |  | PP |  | SIT | 5.10 | Simon Berry | Systems Integration Testing (SIT) | Complete | COMPLETE |  |  |  |  |
| 815 | 1.4.1.4.1.10.2.5 | DIP Onboarding Activity (1. PKI Officers and Certificates, 2. Set-up Validation, 3. End Point Creation, 4. Controlled Smoke Test ) |  | 5d | 2023-12-04 A | 2023-12-08 A | 812FS+6d | 100% | 2023-12-04 | 2023-12-08 | 5d |  |  |  |  | PP |  | SIT | 5.10 | Simon Berry | Systems Integration Testing (SIT) | Complete | COMPLETE |  |  |  |  |
| 816 | 1.4.1.4.1.10.2.6 | DIP Onboarding Complete | milestone | 0d | 2023-12-08 A | 2023-12-08 A | 815 | 100% | 2023-12-08 | 2023-12-08 | 0d |  |  |  |  | PP |  | SIT | 5.10 | Simon Berry | Systems Integration Testing (SIT) | Complete | COMPLETE |  |  |  |  |
| 817 | 1.4.1.4.1.10.2.7 | PPs register PKI Officers and Request PKI Certificates Complete - Interval 6 | milestone | 0d | 2023-12-08 A | 2023-12-08 A | 816 | 100% | 2023-12-08 | 2023-12-08 | 0d | 2023-11-20 | 2023-11-24 | start no earlier than 2023-12-08 |  | PP | DIP Provider | SIT | 5.17 | Simon Berry | Systems Integration Testing (SIT) | Complete | COMPLETE |  | T3-TE-0102 | SITAG | T3 |
| 818 | 1.4.1.4.1.10.2.8 | PP Code Deployment | milestone | 0d | 2024-01-05 A | 2024-01-05 A |  | 100% | 2024-01-05 | 2024-01-05 | 0d |  |  | start no earlier than 2024-01-05 |  | PP |  | SIT | 5.10 | Simon Berry | Systems Integration Testing (SIT) | Complete | COMPLETE |  |  |  |  |

Notes:
- 794: Action: 28/7: CH: Needs to be set-up as a reporting milestone. 31/7: Check with Cesar if has been approved so can be baselined

| ID | WBS | Task | Type | Duration | Start | Finish | Predecessors | Complete | Remaining | Baseline start | Baseline finish | Baseline duration | Baseline 1 start | Baseline 1 finish | Total slack | Constraint | Baseline cost | Responsible | Involved | Text9 | Update Version | MHHS Resource Name | MHHS Programme Phase | Sched Status | RAG | Artefact ID | Milestone ID | Text29 | Tier |
| --- | --- | --- | --- | --- | --- | --- | --- | --- | --- | --- | --- | --- | --- | --- | --- | --- | --- | --- | --- | --- | --- | --- | --- | --- | --- | --- | --- | --- | --- |
| 819 | 1.4.1.4.1.10.3 | **Test Data (SIT A) Interval 6** |  | 25d | 2023-11-20 A | 2023-12-22 A |  | 100% |  | 2023-11-20 | 2023-12-22 | 25d | 2023-11-20 | 2023-12-22 |  |  |  | N/A | N/A | SIT | 5.0 | N/A | Systems Integration Testing (SIT) |  |  |  |  |  |  |
| 820 | 1.4.1.4.1.10.3.1 | Run data allocation |  | 10d | 2023-11-20 A | 2023-12-01 A | 790SS | 100% |  | 2023-11-20 | 2023-12-01 | 5d | 2023-11-20 | 2023-11-24 |  |  |  | SI Test |  | SIT | 5.0 | Richard Puddephatt | Systems Integration Testing (SIT) | Complete | COMPLETE |  |  |  |  |
| 821 | 1.4.1.4.1.10.3.2 | Cleanse and populate data post cut |  | 1d | 2023-12-04 A | 2023-12-04 A | 820 | 100% |  | 2023-12-04 | 2023-12-04 | 5d | 2023-11-27 | 2023-12-01 |  |  |  | SI Test |  | SIT | 5.0 | Richard Puddephatt | Systems Integration Testing (SIT) | Complete | COMPLETE |  |  |  |  |
| 822 | 1.4.1.4.1.10.3.3 | Transmit data sets to PPs |  | 1d | 2023-12-05 A | 2023-12-05 A | 821 | 100% |  | 2023-12-05 | 2023-12-05 | 2d | 2023-12-04 | 2023-12-05 |  |  |  | SI Test |  | SIT | 5.0 | Richard Puddephatt | Systems Integration Testing (SIT) | Complete | COMPLETE |  |  |  |  |
| 823 | 1.4.1.4.1.10.3.4 | PP - Load test data to test environments |  | 8d | 2023-12-06 A | 2023-12-15 A | 822 | 100% |  | 2023-12-06 | 2023-12-15 | 8d | 2023-12-06 | 2023-12-15 |  |  |  | PP |  | SIT | 5.0 | Richard Puddephatt | Systems Integration Testing (SIT) | Complete | COMPLETE |  |  |  |  |
| 824 | 1.4.1.4.1.10.3.5 | PP Check data integrity on test environment |  | 5d | 2023-12-18 A | 2023-12-22 A | 823 | 100% |  | 2023-12-18 | 2023-12-22 | 5d | 2023-12-18 | 2023-12-22 |  |  |  | PP |  | SIT | 5.0 | Richard Puddephatt | Systems Integration Testing (SIT) | Complete | COMPLETE |  |  |  |  |
| 825 | 1.4.1.4.1.10.3.6 | PP submit self-declaration to Programme to confirm loading & verification of test data | milestone | 0d | 2023-12-22 A | 2023-12-22 A | 824FF | 100% |  | 2023-12-22 | 2023-12-22 | 0d | 2023-12-22 | 2023-12-22 |  |  |  | PP | SI Test | SIT | 5.0 | Richard Puddephatt | Systems Integration Testing (SIT) | Complete | COMPLETE |  |  |  |  |
| 826 | 1.4.1.4.1.10.3.7 | Test Data (SIT A) Interval 6 Complete | milestone | 0d | 2023-12-22 A | 2023-12-22 A | 825 | 100% |  | 2023-12-22 | 2023-12-22 | 0d |  |  |  |  |  | SI Test | PP | SIT | 5.5 | Richard Puddephatt | Systems Integration Testing (SIT) | Complete | COMPLETE | MHHS-ART148/169 | T3-TE-0078 | SITAG | T3 |
| 827 | 1.4.1.4.1.10.4 | **Other Preparation** |  | 31d | 2023-12-04 A | 2024-01-15 A |  | 100% |  | 2023-12-04 | 2024-01-15 | 31d | 2023-09-04 | 2023-11-24 |  |  | -0 | N/A | N/A | SIT | 5.0 | N/A | Systems Integration Testing (SIT) |  |  |  |  |  |  |
| 828 | 1.4.1.4.1.10.4.1 | Onboarding of Test Participants to Test Management Tool (Azure DevOps) |  | 31d | 2023-12-04 A | 2024-01-15 A |  | 100% |  | 2023-12-04 | 2024-01-15 | 31d | 2023-09-04 | 2023-11-24 |  | start no earlier than 2023-12-04 |  | SI Test | PP | SIT | 5.0 | Simon Berry | Systems Integration Testing (SIT) | Complete | COMPLETE |  |  |  |  |
| 829 | 1.4.1.4.1.10.4.2 | Test Management Tool onboarding |  | 31d | 2023-12-04 A | 2024-01-15 A |  | 100% |  | 2023-12-04 | 2024-01-15 | 31d | 2023-09-04 | 2023-11-24 |  | start no earlier than 2023-12-04 |  | PP | SI Test | SIT | 5.0 | Simon Berry | Systems Integration Testing (SIT) | Complete | COMPLETE |  |  |  |  |
| 830 | 1.4.1.4.1.10.5 | **SIT Component Integration Test Readiness Report** |  | 25d | 2023-11-20 A | 2023-12-22 A |  | 100% |  | 2023-11-20 | 2023-12-22 | 25d | 2023-12-18 | 2024-01-19 |  |  |  | N/A | N/A | SIT | 5.0 | N/A | Systems Integration Testing (SIT) |  |  |  |  |  |  |
| 831 | 1.4.1.4.1.10.5.1 | PP submit Test Readiness Report to Programme for assurance | milestone | 0d | 2023-12-08 A | 2023-12-08 A | 623 | 100% |  | 2023-12-08 | 2023-12-08 | 0d | 2024-01-05 | 2024-01-05 |  |  |  | PP | SI Test | SIT | 5.0 |  | Systems Integration Testing (SIT) | Complete | COMPLETE |  |  |  |  |
| 832 | 1.4.1.4.1.10.5.2 | SI assure Test Participants' Test Readiness Reports |  | 5d | 2023-12-11 A | 2023-12-15 A | 831FF+5d | 100% |  | 2023-12-11 | 2023-12-15 | 5d | 2024-01-08 | 2024-01-12 |  |  |  | SI Test | PP,IPA | SIT | 5.0 |  | Systems Integration Testing (SIT) | Complete | COMPLETE |  |  |  |  |
| 833 | 1.4.1.4.1.10.5.3 | SI develop Overarching SIT Component Integration Test Readiness Report |  | 20d | 2023-11-20 A | 2023-12-15 A | 832FF | 100% |  | 2023-11-20 | 2023-12-15 | 20d | 2023-12-18 | 2024-01-12 |  |  |  | SI Test |  | SIT | 5.0 |  | Systems Integration Testing (SIT) | Complete | COMPLETE |  |  |  |  |
| 834 | 1.4.1.4.1.10.5.4 | Artefact review (via TMAG) and updates |  | 5d | 2023-12-18 A | 2023-12-22 A | 833 | 100% |  | 2023-12-18 | 2023-12-22 | 5d | 2024-01-15 | 2024-01-19 |  |  |  | SI Test | PP,IPA | SIT | 5.0 |  | Systems Integration Testing (SIT) | Complete | COMPLETE |  |  |  |  |
| 835 | 1.4.1.4.1.10.6 | SIT Component Integration Testing 6 Preparation Complete (incl. approval of SI SIT Component Integration Test Readiness Report) | milestone | 0d | 2024-01-19 A | 2024-01-19 A | 834FS+1d, 808, 812, 829, 831, 826, 294, 466 | 100% |  | 2024-01-19 | 2024-01-19 | 0d | 2024-01-22 | 2024-01-22 |  |  |  | SI Test | PP,IPA | SIT | 5.15 |  | Systems Integration Testing (SIT) | Complete | COMPLETE | MHHS-ART071 | T2-TE-0500 | SITAG | T2 |
| 836 | 1.4.1.4.2 | **SIT Functional Preparation** |  | 595d? | 2022-10-31 A | 2025-02-07 |  | 99% | 3.72d? | 2022-10-31 | 2025-04-07 | 520d | 2022-10-31 | 2024-03-01 | 32322d |  | -0 | N/A | N/A | SIT | 5.0 | N/A | Systems Integration Testing (SIT) |  |  |  |  | SITAG |  |
| 837 | 1.4.1.4.2.1 | Environment Approach and Plan - SIT Functional |  | 1d? | 2023-11-20 A | 2023-11-20 A |  | 100% |  | 2023-11-20 | 2023-11-20 | 0d |  |  |  | start no earlier than 2023-11-20 |  | SI Test |  | SIT | 6.0 |  |  | Complete | COMPLETE |  |  |  |  |
| 838 | 1.4.1.4.2.2 | **Test Approach & Plan** |  | 208d | 2022-10-31 A | 2023-08-16 A |  | 100% |  | 2022-10-31 | 2023-08-16 | 208d | 2022-10-31 | 2023-08-16 |  |  |  | N/A | N/A | SIT | 5.0 | N/A | Systems Integration Testing (SIT) |  |  |  |  |  |  |
| 839 | 1.4.1.4.2.2.1 | Develop document with SITWG |  | 179d | 2022-10-31 A | 2023-07-06 A |  | 100% |  | 2022-10-31 | 2023-07-06 | 179d | 2022-10-31 | 2023-07-06 |  | finish no earlier than 2023-07-06 |  | SI Test |  | SIT | 5.0 |  | Systems Integration Testing (SIT) | Complete | COMPLETE |  |  |  |  |
| 840 | 1.4.1.4.2.2.2 | Industry Consultation |  | 10d | 2023-07-07 A | 2023-07-20 A | 839 | 100% |  | 2023-07-07 | 2023-07-20 | 10d |  |  |  |  |  | PP |  | SIT | 5.1 |  | Systems Integration Testing (SIT) | Complete | COMPLETE |  |  |  |  |
| 841 | 1.4.1.4.2.2.3 | Artefact review (via TMAG) and updates |  | 19d | 2023-07-21 A | 2023-08-16 A | 840 | 100% |  | 2023-07-21 | 2023-08-16 | 19d | 2023-07-07 | 2023-08-03 |  | finish no earlier than 2023-08-03 |  | SI Test | PP,IPA,Code Bodies | SIT | 5.5 |  | Systems Integration Testing (SIT) | Complete | COMPLETE |  |  |  |  |
| 842 | 1.4.1.4.2.2.4 | SIT Functional Test Approach & Plan approved | milestone | 0d | 2023-08-16 A | 2023-08-16 A |  | 100% |  | 2023-08-16 | 2023-08-16 | 0d | 2023-08-16 | 2023-08-16 |  | finish no earlier than 2023-08-16 |  | SI Test | PP | SIT | 5.0 |  | Systems Integration Testing (SIT) | Complete | COMPLETE | MHHS-ART073 | T3-TE-0013 | SITAG | T3 |

Notes:
- 826: Action: 28/7: CH: Needs to be set-up as a reporting milestone. 31/7: Check with Cesar if has been approved so can be baselined

| ID | WBS | Task | Type | Duration | Start | Finish | Predecessors | Complete | Remaining | Baseline start | Baseline finish | Baseline duration | Baseline 1 start | Baseline 1 finish | Total slack | Free slack | Constraint | Baseline cost | Responsible | Involved | Text9 | Update Version | MHHS Resource Name | MHHS Programme Phase | Sched Status | RAG | Artefact ID | Milestone ID | Text29 | Tier | Action | Guidance | Task Status |
| --- | --- | --- | --- | --- | --- | --- | --- | --- | --- | --- | --- | --- | --- | --- | --- | --- | --- | --- | --- | --- | --- | --- | --- | --- | --- | --- | --- | --- | --- | --- | --- | --- | --- |
| 843 | 1.4.1.4.2.3 | **Test Data Approach & Plan** |  | 29d | 2023-07-07 A | 2023-08-16 A |  | 100% |  | 2023-07-07 | 2023-08-16 | 29d | 2023-07-07 | 2023-08-16 |  |  |  |  | N/A | N/A | SIT | 5.0 | N/A | Systems Integration Testing (SIT) |  |  |  |  |  |  |  |  |  |
| 844 | 1.4.1.4.2.3.1 | Industry Consultation |  | 10d | 2023-07-07 A | 2023-07-20 A | 840SS | 100% |  | 2023-07-07 | 2023-07-20 | 10d |  |  |  |  |  |  | PP |  | SIT | 5.1 | Cesar Lopes | Systems Integration Testing (SIT) | Complete | COMPLETE |  |  |  |  |  |  |  |
| 845 | 1.4.1.4.2.3.2 | Artefact review (via TMAG) and updates |  | 19d | 2023-07-21 A | 2023-08-16 A | 844 | 100% |  | 2023-07-21 | 2023-08-16 | 19d | 2023-07-07 | 2023-08-03 |  |  |  |  | SI Test |  | SIT | 5.5 | Cesar Lopes | Systems Integration Testing (SIT) | Complete | COMPLETE |  |  |  |  |  |  |  |
| 846 | 1.4.1.4.2.3.3 | SIT Functional Testing Test Data Approach & Plan approved | milestone | 0d | 2023-08-16 A | 2023-08-16 A | 845 | 100% |  | 2023-08-16 | 2023-08-16 | 0d | 2023-08-16 | 2023-08-16 |  |  |  |  | SI Test | PP,IPA | SIT | 5.5 | Cesar Lopes | Systems Integration Testing (SIT) | Complete | COMPLETE |  |  |  |  |  |  |  |
| 847 | 1.4.1.4.2.4 | **Test scenarios** |  | 298d | 2023-01-02 A | 2024-02-21 A |  | 100% |  | 2023-01-02 | 2024-02-21 | 298d | 2023-01-02 | 2023-06-02 |  |  |  | -0 | N/A | N/A | SIT | 5.0 | N/A | Systems Integration Testing (SIT) |  |  |  |  |  |  |  |  |  |
| 848 | 1.4.1.4.2.4.1 | Development of test scenarios |  | 85d | 2023-01-02 A | 2023-04-28 A | 839SS+45d | 100% |  | 2023-01-02 | 2023-04-28 | 85d | 2023-01-02 | 2023-04-28 |  |  |  |  | SI Test | PP, Code Bodies | SIT | 5.0 |  | Systems Integration Testing (SIT) | Complete | COMPLETE |  |  |  |  |  |  |  |
| 849 | 1.4.1.4.2.4.2 | Review test scenarios with SIT Working Group |  | 65d | 2023-08-17 A | 2023-11-15 A | 848FS+78d | 100% |  | 2023-08-17 | 2023-11-15 | 65d | 2023-02-01 | 2023-05-26 |  |  |  |  | SI Test | PP, Code Bodies, IPA | SIT | 5.0 |  | Systems Integration Testing (SIT) | Complete | COMPLETE |  |  |  |  |  |  |  |
| 850 | 1.4.1.4.2.4.3 | SIT Functional Testing Test scenarios (themes 1-5) approved | milestone | 0d | 2023-12-08 A | 2023-12-08 A | 849FS+17d | 100% |  | 2023-12-08 | 2023-12-08 | 0d | 2023-06-02 | 2023-06-02 |  |  |  |  | SI Test | PP | SIT | 5.14 |  | Systems Integration Testing (SIT) | Complete | COMPLETE | MMHS-ART073 | T3-TE-0015 | SITAG | T3 |  |  |  |
| 851 | 1.4.1.4.2.4.4 | SIT Functional Testing Test scenarios (themes 6,7,9) approved | milestone | 0d | 2024-01-17 A | 2024-01-17 A | 850FS+28d | 100% |  | 2024-01-17 | 2024-01-17 | 0d | 2023-06-02 | 2023-06-02 |  |  |  |  | SI Test | PP | SIT | 5.16 |  | Systems Integration Testing (SIT) | Complete | COMPLETE | MMHS-ART073 | T3-TE-0106 | SITAG | T3 |  |  |  |
| 852 | 1.4.1.4.2.4.5 | SIT Functional Testing Test scenarios (theme 8) approved | milestone | 0d | 2024-02-21 A | 2024-02-21 A | 851FS+25d | 100% |  | 2024-02-21 | 2024-02-21 | 0d | 2023-06-02 | 2023-06-02 |  |  |  |  | SI Test | PP | SIT | 5.14 |  | Systems Integration Testing (SIT) | Complete | COMPLETE | MMHS-ART073 | T3-TE-0107 | SITAG | T3 |  |  |  |
| 853 | 1.4.1.4.2.5 | **Test cases** |  | 465d? | 2023-05-01 A | 2025-02-07 |  | 98% | 7.69d? | 2023-05-01 | 2025-02-07 | 213d | 2023-05-01 | 2023-09-01 | 32322d |  |  |  | N/A | N/A | SIT | 5.0 | N/A | Systems Integration Testing (SIT) |  |  |  |  |  |  | 25/7 - needs to be replanned |  |  |
| 854 | 1.4.1.4.2.5.1 | **SI Test cases** |  | 213d | 2023-05-01 A | 2024-02-21 A |  | 100% |  | 2023-05-01 | 2024-02-21 | 213d | 2023-05-01 | 2023-09-01 |  |  |  |  | N/A | N/A | SIT | 5.0 | N/A | Systems Integration Testing (SIT) |  |  |  |  |  |  | 25/7 - needs to be replanned |  |  |
| 855 | 1.4.1.4.2.5.1.1 | Development of Test cases |  | 150d | 2023-05-01 A | 2023-11-24 A | 848 | 100% |  | 2023-05-01 | 2023-11-24 | 150d | 2023-05-01 | 2023-07-28 |  |  |  |  | SI Test |  | SIT | 5.0 |  | Systems Integration Testing (SIT) | Complete | COMPLETE |  |  |  |  | 25/7 - needs to be replanned |  |  |
| 856 | 1.4.1.4.2.5.1.2 | Review Test cases with SIT Working Group |  | 78d | 2023-09-25 A | 2024-01-10 A | 855SS+105d | 100% |  | 2023-09-25 | 2024-01-10 | 78d | 2023-05-26 | 2023-08-25 |  |  |  |  | SI Test | PP,IPA | SIT | 5.0 |  | Systems Integration Testing (SIT) | Complete | COMPLETE |  |  |  |  | 25/7 - needs to be replanned |  |  |
| 857 | 1.4.1.4.2.5.1.3 | SIT Functional Testing Test Cases (themes 1-5) approved | milestone | 0d | 2024-01-17 A | 2024-01-17 A | 856FS+5d | 100% |  | 2024-01-17 | 2024-01-17 | 0d | 2023-09-01 | 2023-09-01 |  |  |  |  | SI Test | PP | SIT | 5.14 |  | Systems Integration Testing (SIT) | Complete | COMPLETE | MHHS-ART140 | T3-TE-0070 | SITAG | T3 |  | 2/1/24 - Approved at Dec TMAG |  |
| 858 | 1.4.1.4.2.5.1.4 | SIT Functional Testing Test cases (themes 6,7,9) approved | milestone | 0d | 2024-01-17 A | 2024-01-17 A | 857 | 100% |  | 2024-01-17 | 2024-01-17 | 0d | 2023-09-01 | 2023-09-01 |  |  |  |  | SI Test | PP | SIT | 5.14 |  | Systems Integration Testing (SIT) | Complete | COMPLETE | MHHS-ART140 | T3-TE-0108 | SITAG | T3 |  |  |  |
| 859 | 1.4.1.4.2.5.1.5 | SIT Functional Testing Test cases (theme 8) approved | milestone | 0d | 2024-02-21 A | 2024-02-21 A | 858FS+25d | 100% |  | 2024-02-21 | 2024-02-21 | 0d | 2023-09-01 | 2023-09-01 |  |  |  |  | SI Test | PP | SIT | 5.14 |  | Systems Integration Testing (SIT) | Complete | COMPLETE | MHHS-ART140 | T3-TE-0109 | SITAG | T3 |  |  |  |
| 860 | 1.4.1.4.2.5.2 | **SIT Functional Programme RTTM** |  | 74d? | 2024-07-29 A | 2024-11-07 |  | 96% | 3.31d? | 2024-07-29 | 2024-10-11 | 0d |  |  | 32388d |  |  |  | SI Test |  | SIT | 6.0 | Kevin Davis |  | Overdue Start |  |  |  | SITAG |  |  |  | -687.67 |
| 861 | 1.4.1.4.2.5.2.1 | **RTTM Development** |  | 40d? | 2024-07-29 A | 2024-09-20 |  | 89% | 4.57d? | 2024-07-29 | 2024-09-20 | 0d |  |  | 32422d |  |  |  | SI Test |  | SIT | 6.0 | Kevin Davis |  | Overdue Start |  |  |  | SITAG |  |  |  | -693.67 |
| 862 | 1.4.1.4.2.5.2.1.1 | Development of Manual SIT Functional RTTM |  | 30d? | 2024-07-29 A | 2024-09-06 A |  | 100% |  | 2024-07-29 | 2024-09-06 | 0d |  |  |  |  | start no earlier than 2024-07-29 |  | SI Test |  | SIT | 6.0 | Kevin Davis |  | Complete | COMPLETE |  |  | SITAG |  |  |  |  |
| 863 | 1.4.1.4.2.5.2.1.2 | Manual SIT Functional RTTM Complete | milestone | 0d? | 2024-09-06 A | 2024-09-06 A | 862 | 100% |  | 2024-09-06 | 2024-09-06 | 0d |  |  |  |  | start no earlier than 2024-07-29 |  | SI Test |  | SIT | 6.0 | Kevin Davis |  | Complete | COMPLETE |  |  | SITAG |  |  |  |  |
| 864 | 1.4.1.4.2.5.2.1.3 | Development of Automated SIT Functional RTTM |  | 40d? | 2024-07-29 A | 2024-09-20 |  | 80% | 8d? | 2024-07-29 | 2024-09-20 | 0d |  |  | 32422d | 0d | start no earlier than 2024-07-29 |  | SI Test |  | SIT | 6.0 | Roger Robar / Heath Thomas |  | Overdue | RED |  |  | SITAG |  |  |  |  |
| 865 | 1.4.1.4.2.5.2.1.4 | Automated SIT Functional RTTM Complete | milestone | 0d? | 2024-09-20 A | 2024-09-20 | 864 | 80% | 0d? | 2024-09-20 | 2024-09-20 | 0d |  |  | 32422d |  | finish no earlier than 2024-09-20 |  | SI Test |  | SIT | 6.0 | Roger Robar / Heath Thomas |  | Overdue | RED |  |  | SITAG |  |  |  |  |
| 866 | 1.4.1.4.2.5.2.2 | **Gap analysis** |  | 54d? | 2024-08-26 A | 2024-11-07 A |  | 100% |  | 2024-08-26 | 2024-10-11 | 0d |  |  |  |  |  |  | SI Test |  | SIT | 6.0 | Kevin Davis |  | Overdue Start |  |  |  | SITAG |  |  |  | -693.67 |
| 867 | 1.4.1.4.2.5.2.2.1 | Identify gaps in test case coverage following RTTM review |  | 20d? | 2024-08-26 A | 2024-09-20 A | 864SS+20d | 100% |  | 2024-08-26 | 2024-09-20 | 0d |  |  |  |  |  |  | SI Test |  | SIT | 6.0 | Kevin Davis |  | Complete | COMPLETE |  |  | SITAG |  |  |  |  |
| 868 | 1.4.1.4.2.5.2.2.2 | Address gaps in test case coverage following RTTM review |  | 25d | 2024-09-09 A | 2024-10-11 A | 867SS+10d | 100% |  | 2024-09-09 | 2024-10-04 | 0d |  |  |  |  |  |  | SI Test |  | SIT | 6.0 | Kevin Davis |  | Complete | COMPLETE |  |  | SITAG |  |  |  |  |
| 869 | 1.4.1.4.2.5.2.2.3 | Gap analysis complete | milestone | 0d | 2024-10-11 A | 2024-10-11 A | 868 | 100% |  | 2024-10-11 | 2024-10-11 | 0d |  |  |  |  |  |  | SI Test |  | SIT | 6.11 | Kevin Davis |  | Complete | COMPLETE |  |  | SITAG |  |  |  |  |
| 870 | 1.4.1.4.2.5.2.2.4 | Test Script updates identified |  | 1d? | 2024-10-14 A | 2024-10-14 A | 869 | 100% |  | 2024-10-14 | 2024-10-14 | 0d |  |  |  |  |  |  | SI Test |  | SIT | 6.11 | Kevin Davis |  | Complete | COMPLETE |  |  | SITAG |  |  |  |  |
| 871 | 1.4.1.4.2.5.2.2.5 | Test Scripts updates |  | 1d | 2024-10-15 A | 2024-10-15 A | 870 | 100% |  | 2024-10-15 | 2024-10-15 | 0d |  |  |  |  |  |  | SI Test |  | SIT | 6.11 | Kevin Davis |  | Complete | COMPLETE |  |  | SITAG |  |  |  |  |
| 872 | 1.4.1.4.2.5.2.2.6 | RTTM Updated Additional Static RTTM WBS items |  | 10d | 2024-10-14 A | 2024-10-25 A | 870FS-1d | 100% |  | 2024-10-14 | 2024-10-25 | 0d |  |  |  |  |  |  | SI Test |  | SIT | 6.11 | Kevin Davis |  | Complete | COMPLETE |  |  | SITAG |  |  |  |  |
| 873 | 1.4.1.4.2.5.2.2.7 | Removal of de-scoped TCs from the RTTMs |  | 5d | 2024-10-21 A | 2024-10-25 A | 872FS-5d | 100% |  | 2024-10-21 | 2024-10-25 | 0d |  |  |  |  |  |  | SI Test |  | SIT | 6.11 | Kevin Davis |  | Complete | COMPLETE |  |  | SITAG |  |  |  |  |
| 874 | 1.4.1.4.2.5.2.2.8 | Update and stabilisation of all TC ADO IDs |  | 14d | 2024-10-21 A | 2024-11-07 A | 872FS-5d | 100% |  | 2024-10-21 | 2024-10-25 | 0d |  |  |  |  |  |  | SI Test |  | SIT | 6.12 | Kevin Davis |  | Complete | COMPLETE |  |  | SITAG |  |  |  |  |
| 875 | 1.4.1.4.2.5.2.2.9 | Addition and integration of Role tags to reqs in the Role RTTMs |  | 5d | 2024-10-21 A | 2024-10-25 A | 872FS-5d | 100% |  | 2024-10-21 | 2024-10-25 | 0d |  |  |  |  |  |  | SI Test |  | SIT | 6.11 | Kevin Davis |  | Complete | COMPLETE |  |  | SITAG |  |  |  |  |
| 876 | 1.4.1.4.2.5.2.2.10 | Update of the RTTM All sheet (porting of the individual RTTMs) |  | 7d | 2024-10-24 A | 2024-11-01 A | 872FS-2d | 100% |  | 2024-10-24 | 2024-10-25 | 0d |  |  |  |  |  |  | SI Test |  | SIT | 6.11 | Kevin Davis |  | Complete | COMPLETE |  |  | SITAG |  |  |  |  |
| 877 | 1.4.1.4.2.5.2.2.11 | Define Additional ADO Tags |  | 1d | 2024-10-23 A | 2024-10-23 A | 872FS-3d | 100% |  | 2024-10-23 | 2024-10-23 | 0d |  |  |  |  |  |  | SI Test |  | SIT | 6.11 | Kevin Davis |  | Complete | COMPLETE |  |  | SITAG |  |  |  |  |
| 878 | 1.4.1.4.2.5.2.2.12 | Functional RTTM ready for import into ADO | milestone | 0d | 2024-11-01 A | 2024-11-01 A | 876 | 100% |  | 2024-10-25 | 2024-10-25 | 0d |  |  |  |  |  |  | SI Test |  | SIT | 6.11 | Kevin Davis |  | Complete | COMPLETE |  |  | SITAG |  |  |  |  |
| 879 | 1.4.1.4.2.5.2.2.13 | Further Interative Deepdive on the requirements to testcase mapping |  | 9d | 2024-10-21 A | 2024-10-31 A | 876FS-10d | 100% |  | 2024-10-21 | 2024-10-31 | 0d |  |  |  |  |  |  | SI Test |  | SIT | 6.11 | Kevin Davis |  | Complete | COMPLETE |  |  | SITAG |  |  |  |  |
| 880 | 1.4.1.4.2.5.2.2.14 | Internal review |  | 5d | 2024-10-21 A | 2024-10-25 A | 879FS-9d | 100% |  | 2024-11-01 | 2024-11-05 | 0d |  |  |  |  |  |  | SI Test |  | SIT | 6.11 | Kevin Davis |  | Complete | COMPLETE |  |  | SITAG |  |  |  |  |
| 881 | 1.4.1.4.2.5.2.2.15 | Issue Static RTTM to Code Bodies |  | 1d? | 2024-10-29 A | 2024-10-29 A | 880FS+1d | 100% |  | 2024-11-06 | 2024-11-06 | 0d |  |  |  |  |  |  | SI Test |  | SIT | 6.11 | Kevin Davis |  | Complete | COMPLETE |  |  | SITAG |  |  |  |  |
| 882 | 1.4.1.4.2.5.2.2.16 | Code Body Acceptance of RTTM |  | 5d | 2024-10-30 A | 2024-11-05 A | 881 | 100% |  | 2024-11-07 | 2024-11-13 | 0d |  |  |  |  |  |  | Code Bodies |  | SIT | 6.11 | Kevin Davis |  | Complete | COMPLETE |  |  | SITAG |  |  |  |  |

Notes:
- 864: 18/12/24 - Programme and SRO still agreeing a definition of the automated RTTM, action can't be completed until this is done.
- 865: 18/12/24 - Programme and SRO still agreeing a definition of the automated RTTM, action can't be completed until this is done.

| ID | WBS | Task | Type | Duration | Start | Finish | Predecessors | Complete | Baseline start | Baseline finish | Baseline duration | Constraint | Responsible | Text9 | Task Status | Update Version | Sched Status | MHHS Resource Name | Text29 | RAG | Milestone ID | Tier |
| --- | --- | --- | --- | --- | --- | --- | --- | --- | --- | --- | --- | --- | --- | --- | --- | --- | --- | --- | --- | --- | --- | --- |
| 883 | 1.4.1.4.2.5.3 | **Cycle 3 Test Evidence Capturing Approach** |  | 25d? | 2024-09-16 A | 2024-10-18 A |  | 100% | 2024-09-16 | 2024-10-18 | 0d |  | SI Test | SIT | -692.67 | 6.0 | Overdue Start | Ankur Pande | SITAG |  |  |  |
| 884 | 1.4.1.4.2.5.3.1 | Define guiding principles and proof of concept |  | 10d | 2024-09-16 A | 2024-09-27 A |  | 100% | 2024-09-16 | 2024-09-27 | 0d | start no earlier than 2024-09-16 | SI Test | SIT |  | 6.0 | Complete | Ankur Pande | SITAG | COMPLETE |  |  |
| 885 | 1.4.1.4.2.5.3.2 | Draft proposed test evidence capturing approach |  | 3d | 2024-09-30 A | 2024-10-02 A | 884 | 100% | 2024-09-30 | 2024-10-02 | 0d |  | SI Test | SIT |  | 6.0 | Complete | Ankur Pande | SITAG | COMPLETE |  |  |
| 886 | 1.4.1.4.2.5.3.3 | SRO review |  | 5d | 2024-10-03 A | 2024-10-09 A | 885 | 100% | 2024-10-03 | 2024-10-09 | 0d |  | SI Test | SIT |  | 6.0 | Complete | Ankur Pande | SITAG | COMPLETE |  |  |
| 887 | 1.4.1.4.2.5.3.4 | Present proposed approach |  | 1d? | 2024-10-11 A | 2024-10-11 A | 886FS+1d | 100% | 2024-10-11 | 2024-10-11 | 0d |  | SI Test | SIT |  | 6.0 | Complete | Ankur Pande | SITAG | COMPLETE |  |  |
| 888 | 1.4.1.4.2.5.3.5 | Incorporate feedback |  | 4d | 2024-10-14 A | 2024-10-17 A | 887 | 100% | 2024-10-14 | 2024-10-17 | 0d |  | SI Test | SIT |  | 6.0 | Complete | Ankur Pande | SITAG | COMPLETE |  |  |
| 889 | 1.4.1.4.2.5.3.6 | Publish proposed approach ahead of Cycle 3 start |  | 1d? | 2024-10-18 A | 2024-10-18 A | 888 | 100% | 2024-10-18 | 2024-10-18 | 0d |  | SI Test | SIT |  | 6.0 | Complete | Ankur Pande | SITAG | COMPLETE |  |  |
| 890 | 1.4.1.4.2.5.4 | **DITL Cycle 3 Pack Development** |  | 8d? | 2024-10-08 A | 2024-10-17 A |  | 100% | 2024-10-08 | 2024-10-17 | 0d |  | SI Test | SIT | 6.33 | 6.0 | No BL | Dom Mooney | SITAG |  |  |  |
| 891 | 1.4.1.4.2.5.4.1 | Programme Cycle 2 Retro |  | 1d? | 2024-10-08 A | 2024-10-08 A |  | 100% | 2024-10-08 | 2024-10-08 | 0d | start no earlier than 2024-10-08 | SI Test | SIT |  | 6.0 | Complete | Dom Mooney | SITAG | COMPLETE |  |  |
| 892 | 1.4.1.4.2.5.4.2 | Post-retro DITL Changes |  | 3d | 2024-10-09 A | 2024-10-11 A | 891 | 100% | 2024-10-09 | 2024-10-11 | 0d |  | SI Test | SIT |  | 6.0 | Complete | Dom Mooney | SITAG | COMPLETE |  |  |
| 893 | 1.4.1.4.2.5.4.3 | SRO Review |  | 2d | 2024-10-14 A | 2024-10-15 A | 892 | 100% | 2024-10-14 | 2024-10-15 | 0d |  | SI Test | SIT |  | 6.0 | Complete | Dom Mooney | SITAG | COMPLETE |  |  |
| 894 | 1.4.1.4.2.5.4.4 | Post-SRO Review Changes |  | 1d? | 2024-10-16 A | 2024-10-16 A | 893 | 100% | 2024-10-16 | 2024-10-16 | 0d |  | SI Test | SIT |  | 6.0 | Complete | Dom Mooney | SITAG | COMPLETE |  |  |
| 895 | 1.4.1.4.2.5.4.5 | Publish Cycle 3 DITL / Cycle 3 DITL Online Sessions for SIT PPs |  | 1d? | 2024-10-17 A | 2024-10-17 A | 894 | 100% | 2024-10-17 | 2024-10-17 | 0d |  | SI Test, PPs | SIT |  | 6.0 | Complete | Dom Mooney | SITAG | COMPLETE |  |  |
| 896 | 1.4.1.4.2.5.5 | **Test Script Exit Points** |  | 85d | 2024-10-14 A | 2025-02-07 A |  | 100% | 2024-10-14 | 2025-02-07 | 0d |  | SI Test | SIT | -694.67 | 6.0 | Overdue Start | Kevin Davis | SITAG |  |  |  |
| 897 | 1.4.1.4.2.5.5.1 | Implement exit points for Sprint 5 |  | 5d | 2024-10-14 A | 2024-10-18 A | 889FS-5d | 100% | 2024-10-14 | 2024-10-18 | 0d |  | SI Test | SIT |  | 6.0 | Complete | Kevin Davis | SITAG | COMPLETE |  |  |
| 898 | 1.4.1.4.2.5.5.2 | Identify exit points for Sprint 6 |  | 5d | 2024-11-07 A | 2024-11-13 A | 1513SS | 100% | 2024-10-21 | 2024-10-25 | 0d |  | SI Test | SIT |  | 6.0 | Complete | Kevin Davis | SITAG | COMPLETE |  |  |
| 899 | 1.4.1.4.2.5.5.3 | Identify exit points for Sprint 7 |  | 5d | 2024-11-08 A | 2024-11-14 A | 1514SS | 100% | 2024-11-04 | 2024-11-08 | 0d | start no earlier than 2024-11-08 | SI Test | SIT |  | 6.0 | Complete | Kevin Davis | SITAG | COMPLETE |  |  |
| 900 | 1.4.1.4.2.5.5.4 | Identify exit points for Sprint 8 |  | 5d | 2024-11-18 A | 2024-11-22 A | 1515SS | 100% | 2024-11-18 | 2024-11-22 | 0d |  | SI Test | SIT |  | 6.0 | Complete | Kevin Davis | SITAG | COMPLETE |  |  |
| 901 | 1.4.1.4.2.5.5.5 | Identify exit points for Sprint 9 |  | 5d | 2024-12-02 A | 2024-12-06 A | 1516SS | 100% | 2024-12-02 | 2024-12-06 | 0d |  | SI Test | SIT |  | 6.0 | Complete | Kevin Davis | SITAG | COMPLETE |  |  |
| 902 | 1.4.1.4.2.5.5.6 | Identify exit points for Sprint 10 |  | 5d | 2024-12-23 A | 2024-12-27 A | 1517SS | 100% | 2024-12-23 | 2024-12-27 | 0d |  | SI Test | SIT |  | 6.0 | Complete | Kevin Davis | SITAG | COMPLETE |  |  |
| 903 | 1.4.1.4.2.5.5.7 | Identify exit points for Sprint 11 |  | 5d | 2025-01-06 A | 2025-01-10 A | 1518SS | 100% | 2025-01-06 | 2025-01-10 | 0d |  | SI Test | SIT |  | 6.0 | Complete | Kevin Davis | SITAG | COMPLETE |  |  |
| 904 | 1.4.1.4.2.5.5.8 | Identify exit points for Sprint 12 |  | 5d | 2025-01-20 A | 2025-01-24 A | 1519SS | 100% | 2025-01-20 | 2025-01-24 | 0d |  | SI Test | SIT |  | 6.0 | Complete | Kevin Davis | SITAG | COMPLETE |  |  |
| 905 | 1.4.1.4.2.5.5.9 | Identify exit points for Sprint 13 |  | 5d | 2025-02-03 A | 2025-02-07 A | 1520SS | 100% | 2025-02-03 | 2025-02-07 | 0d |  | SI Test | SIT |  | 6.0 | Complete | Kevin Davis | SITAG | COMPLETE |  |  |
| 906 | 1.4.1.4.2.5.5.10 | Exit point identified and evidence capture flags updated | milestone | 0d | 2025-02-07 A | 2025-02-07 A | 905 | 100% | 2025-02-07 | 2025-02-07 | 0d |  | SI Test | SIT |  | 6.13 | Complete | Kevin Davis | SITAG | COMPLETE | T3-TE-0125 | T3 |

| ID | WBS | Task | Type | Duration | Start | Finish | Predecessors | Complete | Baseline start | Baseline finish | Baseline duration | Baseline 1 start | Baseline 1 finish | Constraint | Baseline cost | Responsible | Involved | Text9 | Update Version | MHHS Resource Name | MHHS Programme Phase | Text29 | Task Status | Sched Status | RAG | Action | Milestone ID | Tier | Artefact ID |
| --- | --- | --- | --- | --- | --- | --- | --- | --- | --- | --- | --- | --- | --- | --- | --- | --- | --- | --- | --- | --- | --- | --- | --- | --- | --- | --- | --- | --- | --- |
| 907 | 1.4.1.4.2.6 | **Environments (SIT-Staging)** |  | 10d | 2023-12-04 A | 2023-12-15 A |  | 100% | 2023-12-04 | 2023-12-15 | 323d | 2022-11-16 | 2024-02-09 |  |  | N/A | N/A | SIT | 5.0 | N/A | Systems Integration Testing (SIT) | SITAG |  |  |  |  |  |  |  |
| 908 | 1.4.1.4.2.6.1 | **SIT Functional pre-requisites** |  | 10d | 2023-12-04 A | 2023-12-15 A |  | 100% | 2023-12-04 | 2023-12-15 | 10d |  |  |  |  | N/A | N/A | SIT | 5.3 | N/A | Systems Integration Testing (SIT) | SITAG |  |  |  |  |  |  |  |
| 909 | 1.4.1.4.2.6.1.1 | **DCC** |  | 10d | 2023-12-04 A | 2023-12-15 A |  | 100% | 2023-12-04 | 2023-12-15 | 10d |  |  |  |  | N/A | N/A | SIT | 5.3 | N/A | Systems Integration Testing (SIT) | SITAG | -254.67 |  |  |  |  |  |  |
| 910 | 1.4.1.4.2.6.1.1.1 | **CSS** |  | 10d | 2023-12-04 A | 2023-12-15 A |  | 100% | 2023-12-04 | 2023-12-15 | 10d |  |  |  |  | N/A | N/A | SIT | 5.3 | N/A | Systems Integration Testing (SIT) | SITAG | -254.67 |  |  |  |  |  |  |
| 911 | 1.4.1.4.2.6.1.1.1.1 | SIT participants have requested DCC CSS PKI certificates for access to UIT-B environment |  | 10d | 2023-12-04 A | 2023-12-15 A |  | 100% | 2023-12-04 | 2023-12-15 | 10d |  |  | start no earlier than 2023-12-04 |  | SIT Participants (Suppliers & Third Parties) | PP | SIT | 5.3 | Simon Berry | Systems Integration Testing (SIT) | SITAG |  | Complete | COMPLETE |  |  |  |  |
| 912 | 1.4.1.4.2.6.1.1.1.2 | SIT participants have received DCC CSS PKI certificates for UIT-B environment | milestone | 0d | 2023-12-15 A | 2023-12-15 A | 911 | 100% | 2023-12-15 | 2023-12-15 | 0d |  |  |  |  | SIT Participants (Suppliers & Third Parties) | PP | SIT | 5.5 | Simon Berry | Systems Integration Testing (SIT) | SITAG |  | Complete | COMPLETE | 7/8 - added as a T3 milestone. Awaiting approval at TMAG | T3-TE-0088 | T3 |  |
| 913 | 1.4.1.4.2.6.1.1.2 | **DSP** |  | 10d | 2023-12-04 A | 2023-12-15 A |  | 100% | 2023-12-04 | 2023-12-15 | 10d |  |  |  |  | N/A | N/A | SIT | 5.3 | N/A | Systems Integration Testing (SIT) | SITAG | -254.67 |  |  |  |  |  |  |
| 914 | 1.4.1.4.2.6.1.1.2.1 | SIT participants have requested DCC DSP PKI certificates for access to UIT-B environment |  | 10d | 2023-12-04 A | 2023-12-15 A |  | 100% | 2023-12-04 | 2023-12-15 | 10d |  |  | start no earlier than 2023-12-04 |  | PPs in SDS Market Role | PP | SIT | 5.3 | Simon Berry | Systems Integration Testing (SIT) | SITAG |  | Complete | COMPLETE |  |  |  |  |
| 915 | 1.4.1.4.2.6.1.1.2.2 | SIT participants have received DCC DSP PKI certificates for UIT-B environment | milestone | 0d | 2023-12-15 A | 2023-12-15 A | 914 | 100% | 2023-12-15 | 2023-12-15 | 0d |  |  |  |  | PPs in SDS Market Role | PP | SIT | 5.5 | Simon Berry | Systems Integration Testing (SIT) | SITAG |  | Complete | COMPLETE | 7/8 - added as a T3 milestone. Awaiting approval at TMAG | T3-TE-0089 | T3 |  |
| 916 | 1.4.1.4.2.7 | **Stand up SIT A Environment** |  | 25d | 2024-02-05 A | 2024-03-08 A |  | 100% | 2024-02-05 | 2024-03-08 | 25d | 2024-02-05 | 2024-02-09 |  |  | N/A | N/A | SIT | 6.0 | N/A | Systems Integration Testing (SIT) | SITAG |  |  |  |  |  |  |  |
| 917 | 1.4.1.4.2.7.1 | **SIT Functional Connectivity Proving** |  | 15d | 2024-02-12 A | 2024-03-01 A |  | 100% | 2024-02-12 | 2024-03-01 | 20d |  |  |  |  | N/A | N/A | SIT | 5.5 | N/A | Systems Integration Testing (SIT) | SITAG | -288.67 |  |  |  |  |  |  |
| 918 | 1.4.1.4.2.7.1.1 | SIT Functional Connectivity Proving Period |  | 15d | 2024-02-12 A | 2024-03-01 A |  | 100% | 2024-02-12 | 2024-03-01 | 20d |  |  | start no earlier than 2024-01-08 |  | SI Test | PP | SIT | 5.19 | Simon Berry | Systems Integration Testing (SIT) | SITAG |  | Complete | COMPLETE |  |  |  |  |
| 919 | 1.4.1.4.2.7.1.2 | SIT Functional Connectivity Proving Complete | milestone | 0d | 2024-03-01 A | 2024-03-01 A | 918 | 100% | 2024-03-01 | 2024-03-01 | 0d |  |  | start no earlier than 2024-03-01 |  | SI Test | PP | SIT | 5.19 | Simon Berry | Systems Integration Testing (SIT) | SITAG |  | Complete | COMPLETE |  | T3-TE-0103 | T3 |  |
| 920 | 1.4.1.4.2.7.2 | **PP Environments (SIT A)** |  | 25d | 2024-02-05 A | 2024-03-08 A |  | 100% | 2024-02-05 | 2024-03-08 | 5d | 2024-02-05 | 2024-02-09 |  |  | N/A | N/A | SIT | 5.0 | N/A | Systems Integration Testing (SIT) | SITAG |  |  |  |  |  |  |  |
| 921 | 1.4.1.4.2.7.2.1 | Deployment of MHHS solution code to SIT A environments |  | 25d | 2024-02-05 A | 2024-03-08 A |  | 100% | 2024-02-05 | 2024-03-08 | 5d | 2024-02-05 | 2024-02-09 | start no earlier than 2024-02-05 |  | PP | SI Test | SIT | 5.0 | Simon Berry | Systems Integration Testing (SIT) | SITAG |  | Complete | COMPLETE |  |  |  |  |
| 922 | 1.4.1.4.2.7.3 | **SI Environments (SIT A)** |  | 25d | 2024-02-05 A | 2024-03-08 A |  | 100% | 2024-02-05 | 2024-03-08 | 5d | 2024-02-05 | 2024-02-09 |  |  | N/A | N/A | SIT | 5.0 | N/A | Systems Integration Testing (SIT) | SITAG |  |  |  |  |  |  |  |
| 923 | 1.4.1.4.2.7.3.1 | Coordinate deployment of MHHS solution code to SIT Participants' SIT A environments |  | 25d | 2024-02-05 A | 2024-03-08 A | 921SS | 100% | 2024-02-05 | 2024-03-08 | 5d | 2024-02-05 | 2024-02-09 |  |  | SI Test | PP | SIT | 5.0 | Simon Berry | Systems Integration Testing (SIT) | SITAG |  | Complete | COMPLETE |  |  |  |  |
| 924 | 1.4.1.4.2.8 | **Test data (SIT A)** |  | 221d? | 2023-12-18 A | 2024-10-21 A |  | 100% | 2023-12-18 | 2025-04-07 | 225d |  |  |  | -0 | N/A | N/A | SIT | 5.4 | N/A | Systems Integration Testing (SIT) | SITAG | -269.67 |  |  |  |  |  |  |
| 925 | 1.4.1.4.2.8.1 | **Cycle 1 Test data (SIT A)** |  | 55d | 2023-12-18 A | 2024-03-01 A |  | 100% | 2023-12-18 | 2024-03-01 | 55d |  |  |  | -0 | N/A | N/A | SIT | 5.4 | N/A | Systems Integration Testing (SIT) | SITAG | -269.67 |  |  |  |  |  |  |
| 926 | 1.4.1.4.2.8.1.1 | Prepare, Generate and Allocate Test Data |  | 28d | 2023-12-18 A | 2024-01-24 A | 655, 663 | 100% | 2023-12-18 | 2024-01-24 | 28d |  |  | start no earlier than 2023-12-11 |  | SI Test Data |  | SIT | 5.14 | Richard Puddephatt | Systems Integration Testing (SIT) | SITAG |  | Complete | COMPLETE |  |  |  |  |
| 927 | 1.4.1.4.2.8.1.2 | Transmit Data Sets to PPs |  | 4d | 2024-01-26 A | 2024-01-31 A | 926FS+1d | 100% | 2024-01-26 | 2024-01-31 | 2d |  |  |  |  | SI Test Data |  | SIT | 5.14 | Richard Puddephatt | Systems Integration Testing (SIT) | SITAG |  | Complete | COMPLETE |  |  |  |  |
| 928 | 1.4.1.4.2.8.1.3 | PP's Iterative load and data integrity check |  | 22d | 2024-02-01 A | 2024-03-01 A | 927 | 100% | 2024-02-01 | 2024-03-01 | 10d |  |  |  |  | PP |  | SIT | 5.14 | Richard Puddephatt | Systems Integration Testing (SIT) | SITAG |  | Complete | COMPLETE |  |  |  |  |
| 929 | 1.4.1.4.2.8.1.4 | Cycle 1 - PP's confirmation that test data is ready for SIT Functional | milestone | 0d | 2024-03-01 A | 2024-03-01 A | 928 | 100% | 2024-03-01 | 2024-03-01 | 0d |  |  |  |  | SI Test Data |  | SIT | 5.18 | Richard Puddephatt | Systems Integration Testing (SIT) | SITAG |  | Complete | COMPLETE | 2/8 - added as a T3 milestone. Awaiting approval at TMAG | T3-TE-0079 | T3 | MHHS-ART140 MHHS-ART169 |
| 930 | 1.4.1.4.2.8.2 | **Cycle 2 Test data (inc. Settlement Data) (SIT A)** |  | 57d | 2024-03-28 A | 2024-06-14 A |  | 100% | 2024-03-28 | 2024-06-14 | 47d |  |  |  | -0 | N/A | N/A | SIT | 6.0 | N/A | Systems Integration Testing (SIT) | SITAG |  |  |  |  |  |  |  |
| 931 | 1.4.1.4.2.8.2.1 | Prepare, Generate and Allocate Test Data |  | 31d | 2024-03-28 A | 2024-05-09 A | 929FS+18d | 100% | 2024-03-28 | 2024-05-09 | 31d |  |  |  |  | SI Test Data |  | SIT | 5.14 | Richard Puddephatt | Systems Integration Testing (SIT) | SITAG |  | Complete | COMPLETE |  |  |  |  |
| 932 | 1.4.1.4.2.8.2.2 | Transmit Data Sets to PPs |  | 3d | 2024-05-10 A | 2024-05-14 A | 931 | 100% | 2024-05-10 | 2024-05-14 | 3d |  |  |  |  | SI Test Data |  | SIT | 5.14 | Richard Puddephatt | Systems Integration Testing (SIT) | SITAG |  | Complete | COMPLETE |  |  |  |  |
| 933 | 1.4.1.4.2.8.2.3 | PP's Iterative load and data integrity check |  | 13d | 2024-05-15 A | 2024-05-31 A | 932 | 100% | 2024-05-15 | 2024-05-31 | 13d |  |  |  |  | PP |  | SIT | 5.14 | Richard Puddephatt | Systems Integration Testing (SIT) | SITAG |  | Complete | COMPLETE |  |  |  |  |
| 934 | 1.4.1.4.2.8.2.4 | Cycle 2 - PP's confirmation that test data is ready for SIT Functional | milestone | 0d | 2024-06-14 A | 2024-06-14 A | 933FS+10d | 100% | 2024-06-14 | 2024-06-14 | 0d |  |  |  |  | SI Test Data |  | SIT | 5.27 | Richard Puddephatt | Systems Integration Testing (SIT) | SITAG |  | Complete | COMPLETE | 2/8 - added as a T3 milestone. Awaiting approval at TMAG | T3-TE-0080 | T3 | MHHS-ART140 MHHS-ART169 |

| ID | WBS | Task | Duration | Start | Finish | Predecessors | Complete | Baseline start | Baseline finish | Baseline duration | Baseline 1 start | Baseline 1 finish | Constraint | Baseline cost | Responsible | Involved | Text9 | Update Version | Sched Status | MHHS Resource Name | MHHS Programme Phase | Text29 | RAG | Milestone ID |
| --- | --- | --- | --- | --- | --- | --- | --- | --- | --- | --- | --- | --- | --- | --- | --- | --- | --- | --- | --- | --- | --- | --- | --- | --- |
| 935 | 1.4.1.4.2.8.3 | **Cycle 3 Test data (SIT A) (2)** | 71d? | 2024-07-15 A | 2024-10-21 A |  | 100% | 2024-07-15 | 2024-10-21 | 41d |  |  |  | -0 | N/A | N/A | SIT | 5.4 | Overdue | N/A | Systems Integration Testing (SIT) | SITAG |  |  |
| 936 | 1.4.1.4.2.8.3.1 | Cycle 3 data requirments analysis - check Cycle 2 data for gaps Check blocked test cases | 10d? | 2024-07-15 A | 2024-07-26 A |  | 100% | 2024-07-15 | 2024-07-26 | 0d |  |  | finish no earlier than 2024-07-26 |  |  |  | SIT | 6.0 | Complete | Richard Puddephatt |  | SITAG | COMPLETE |  |
| 937 | 1.4.1.4.2.8.3.2 | Provide DCC with MPANS for deletion secure file with password | 1d? | 2024-08-12 A | 2024-08-12 A |  | 100% | 2024-08-12 | 2024-08-12 | 0d |  |  |  |  |  |  | SIT | 6.0 | Complete | Richard Puddephatt |  | SITAG | COMPLETE |  |
| 938 | 1.4.1.4.2.8.3.3 | Receive MPANS from DCC to exclude | 1d? | 2024-08-09 A | 2024-08-09 A |  | 100% | 2024-08-09 | 2024-08-09 | 0d |  |  |  |  |  |  | SIT | 6.0 | Complete | Richard Puddephatt |  | SITAG | COMPLETE |  |
| 939 | 1.4.1.4.2.8.3.4 | Exclude MPANS from allocation | 1d | 2024-08-16 A | 2024-08-16 A |  | 100% | 2024-08-16 | 2024-08-16 | 0d |  |  |  |  |  |  | SIT | 6.0 | Complete | Richard Puddephatt |  | SITAG | COMPLETE |  |
| 940 | 1.4.1.4.2.8.3.5 | Allocate Cycle 3 MPANS | 16d? | 2024-08-06 A | 2024-08-27 A |  | 100% | 2024-08-06 | 2024-08-27 | 0d |  |  |  |  |  |  | SIT | 6.0 | Complete | Richard Puddephatt |  | SITAG | COMPLETE |  |
| 941 | 1.4.1.4.2.8.3.6 | Generate Cycle 3 Data | 2d? | 2024-08-27 A | 2024-08-28 A |  | 100% | 2024-08-27 | 2024-08-28 | 0d |  |  |  |  |  |  | SIT | 6.0 | Complete | Richard Puddephatt |  | SITAG | COMPLETE |  |
| 942 | 1.4.1.4.2.8.3.7 | Check data prior to sending to DCC | 5d? | 2024-08-22 A | 2024-08-28 A |  | 100% | 2024-08-22 | 2024-08-28 | 0d |  |  |  |  |  |  | SIT | 6.0 | Complete | Richard Puddephatt |  | SITAG | COMPLETE |  |
| 943 | 1.4.1.4.2.8.3.8 | Share Cycle 3 MPAN data with DCC | 1d? | 2024-08-29 A | 2024-08-29 A |  | 100% | 2024-08-29 | 2024-08-29 | 0d |  |  |  |  |  |  | SIT | 6.0 | Complete | Richard Puddephatt |  | SITAG | COMPLETE |  |
| 944 | 1.4.1.4.2.8.3.9 | DCC - load data and create registration Id's for Cycle 3 data | 13d? | 2024-08-27 A | 2024-09-12 A |  | 100% | 2024-08-27 | 2024-09-12 | 0d |  |  |  |  |  |  | SIT | 6.0 | Complete | Richard Puddephatt |  | SITAG | COMPLETE |  |
| 945 | 1.4.1.4.2.8.3.10 | Add registration ID's to Cycle 3 Data | 2d? | 2024-09-12 A | 2024-09-13 A |  | 100% | 2024-09-12 | 2024-09-13 | 0d |  |  |  |  |  |  | SIT | 6.0 | Complete | Richard Puddephatt |  | SITAG | COMPLETE |  |
| 946 | 1.4.1.4.2.8.3.11 | Share subset of data with St Cls for data load | 2d? | 2024-09-12 A | 2024-09-13 A |  | 100% | 2024-09-12 | 2024-09-13 | 0d |  |  |  |  |  |  | SIT | 6.0 | Complete | Richard Puddephatt |  | SITAG | COMPLETE |  |
| 947 | 1.4.1.4.2.8.3.12 | St Clements to run test with Subset of data - MPRS business process checks including Import/Export MPANS | 5d? | 2024-09-16 A | 2024-09-20 A |  | 100% | 2024-09-16 | 2024-09-20 | 0d |  |  |  |  |  |  | SIT | 6.0 | Complete | Richard Puddephatt |  | SITAG | COMPLETE |  |
| 948 | 1.4.1.4.2.8.3.13 | Send Cycle 3 data to partcipants for early sight of data | 3d? | 2024-09-25 A | 2024-09-27 A |  | 100% | 2024-09-25 | 2024-09-27 | 0d |  |  |  |  |  |  | SIT | 6.0 | Complete | Richard Puddephatt |  | SITAG | COMPLETE |  |
| 949 | 1.4.1.4.2.8.3.14 | St Clements MPRS data load bulk files for Cycle 3 | 15d? | 2024-09-23 A | 2024-10-11 A |  | 100% | 2024-09-23 | 2024-10-11 | 0d |  |  |  |  |  |  | SIT | 6.0 | Complete | Richard Puddephatt |  | SITAG | COMPLETE |  |
| 950 | 1.4.1.4.2.8.3.15 | New MPAN creation and load through DCC and St Clements | 1d? | 2024-10-11 A | 2024-10-11 A |  | 100% | 2024-10-11 | 2024-10-11 | 0d |  |  | start no earlier than 2024-10-11 |  |  |  | SIT | 6.0 | Complete | Richard Puddephatt |  | SITAG | COMPLETE |  |
| 951 | 1.4.1.4.2.8.3.16 | Share files with PP's and central parties | 1d | 2024-10-11 A | 2024-10-11 A |  | 100% | 2024-10-11 | 2024-10-11 | 0d |  |  | start no earlier than 2024-10-11 |  |  |  | SIT | 6.0 | Complete | Richard Puddephatt |  | SITAG | COMPLETE |  |
| 952 | 1.4.1.4.2.8.3.17 | Avanade to load data | 6d | 2024-10-14 A | 2024-10-21 A |  | 100% | 2024-10-14 | 2024-10-21 | 0d |  |  | start no earlier than 2024-10-14 |  |  |  | SIT | 6.0 | Complete | Richard Puddephatt |  | SITAG | COMPLETE |  |
| 953 | 1.4.1.4.2.8.3.18 | Helix to load data | 6d | 2024-10-14 A | 2024-10-21 A |  | 100% | 2024-10-14 | 2024-10-21 | 0d |  |  | start no earlier than 2024-10-14 |  |  |  | SIT | 6.0 | Complete | Richard Puddephatt |  | SITAG | COMPLETE |  |
| 954 | 1.4.1.4.2.8.3.19 | PP's and central parties to load all Cycle 3 data | 6d | 2024-10-14 A | 2024-10-21 A |  | 100% | 2024-10-14 | 2024-10-21 | 0d |  |  | start no earlier than 2024-10-14 |  |  |  | SIT | 6.0 | Complete | Richard Puddephatt |  | SITAG | COMPLETE |  |
| 955 | 1.4.1.4.2.8.3.20 | All parties to finalise data load | 1d? | 2024-10-21 A | 2024-10-21 A |  | 100% | 2024-10-21 | 2024-10-21 | 0d |  |  | start no earlier than 2024-10-21 |  | SI Data |  | SIT | 6.0 | Complete | Richard Puddephatt |  | SITAG | COMPLETE | T3-TE-0081 |
| 956 | 1.4.1.4.2.9 | **SIT Functional Test Readiness Report** | 45d | 2024-01-01 A | 2024-03-01 A |  | 100% | 2024-01-01 | 2024-03-01 | 44d | 2024-01-01 | 2024-02-23 |  | -0 | N/A | N/A | SIT | 5.0 |  | N/A | Systems Integration Testing (SIT) | SITAG |  |  |
| 957 | 1.4.1.4.2.9.1 | **PP SIT Functional Test Readiness Report** | 44d | 2024-01-01 A | 2024-02-29 A |  | 100% | 2024-01-01 | 2024-02-29 | 44d | 2024-01-01 | 2024-02-09 |  | -0 | N/A | N/A | SIT | 5.0 |  | N/A | Systems Integration Testing (SIT) | SITAG |  |  |
| 958 | 1.4.1.4.2.9.1.1 | Develop draft Test Readiness Report and submit to Programme for assurance | 21d | 2024-01-01 A | 2024-01-29 A |  | 100% | 2024-01-01 | 2024-01-29 | 20d | 2024-01-01 | 2024-01-29 | start no earlier than 2024-01-01 |  | PP | SI Test | SIT | 5.0 | Complete |  | Systems Integration Testing (SIT) | SITAG | COMPLETE |  |
| 959 | 1.4.1.4.2.9.1.2 | Placing Reliance Stage 2 Review | 34d | 2024-01-15 A | 2024-02-29 A | 958SS+10d | 100% | 2024-01-15 | 2024-02-29 | 34d |  |  |  |  | SI Test | PP | SIT | 5.12 | Complete |  | Systems Integration Testing (SIT) | SITAG | COMPLETE |  |
| 960 | 1.4.1.4.2.9.1.3 | Finalise Test Readiness Report and submit to Programme for assurance | 9d | 2024-01-30 A | 2024-02-09 A | 958 | 100% | 2024-01-30 | 2024-02-09 | 10d | 2024-01-29 | 2024-02-09 |  |  | PP | SI Test | SIT | 5.0 | Complete |  | Systems Integration Testing (SIT) | SITAG | COMPLETE |  |

| ID | WBS | Task | Type | Duration | Start | Finish | Predecessors | Complete | Remaining | Baseline start | Baseline finish | Baseline duration | Baseline 1 start | Baseline 1 finish | Total slack | Constraint | Baseline cost | Responsible | Involved | Text9 | Update Version | MHHS Resource Name | MHHS Programme Phase | Text29 | Sched Status | RAG | Milestone ID | Tier | Artefact ID | Task Status |
| --- | --- | --- | --- | --- | --- | --- | --- | --- | --- | --- | --- | --- | --- | --- | --- | --- | --- | --- | --- | --- | --- | --- | --- | --- | --- | --- | --- | --- | --- | --- |
| 961 | 1.4.1.4.2.9.2 | **SI SIT Functional Test Readiness Report** |  | 40d | 2024-01-01 A | 2024-02-23 A |  | 100% |  | 2024-01-01 | 2024-02-23 | 40d | 2024-01-01 | 2024-02-23 |  |  |  | N/A | N/A | SIT | 5.0 | N/A | Systems Integration Testing (SIT) | SITAG |  |  |  |  |  |  |
| 962 | 1.4.1.4.2.9.2.1 | Assure Test Participants' Test Readiness Reports |  | 35d | 2024-01-01 A | 2024-02-16 A | 958SS, 960FF+5d | 100% |  | 2024-01-01 | 2024-02-16 | 35d | 2024-01-01 | 2024-02-16 |  |  |  | SI Test | PP,IPA | SIT | 5.0 |  | Systems Integration Testing (SIT) | SITAG | Complete | COMPLETE |  |  |  |  |
| 963 | 1.4.1.4.2.9.2.2 | Develop Overarching SIT Functional Test Readiness Report |  | 20d | 2024-01-22 A | 2024-02-16 A | 962FF | 100% |  | 2024-01-22 | 2024-02-16 | 20d | 2024-01-22 | 2024-02-16 |  |  |  | SI Test |  | SIT | 5.0 |  | Systems Integration Testing (SIT) | SITAG | Complete | COMPLETE |  |  |  |  |
| 964 | 1.4.1.4.2.9.2.3 | Artefact review (via TMAG) and updates |  | 5d | 2024-02-19 A | 2024-02-23 A | 963 | 100% |  | 2024-02-19 | 2024-02-23 | 5d | 2024-02-19 | 2024-02-23 |  |  |  | SI Test | PP,IPA | SIT | 5.0 |  | Systems Integration Testing (SIT) | SITAG | Complete | COMPLETE |  |  |  |  |
| 965 | 1.4.1.4.2.9.3 | SIT Functional Testing Preparation Complete | milestone | 0d | 2024-03-01 A | 2024-03-01 A | 964FF+5d, 842, 363, 959, 850, 857, 929 | 100% |  | 2024-03-01 | 2024-03-01 | 0d | 2024-03-01 | 2024-03-01 |  |  |  | SI Test | PP,IPA | SIT | 5.0 |  | Systems Integration Testing (SIT) | SITAG | Complete | COMPLETE | T2-TE-0550 | T2 |  |  |
| 966 | 1.4.1.4.3 | **SIT Migration Testing Preparation** |  | 590d? | 2022-10-31 A | 2025-01-31 |  | 91% | 51.32d? | 2022-10-31 | 2024-10-04 | 420d | 2022-11-16 | 2024-06-03 | 32327d |  | -0 | N/A | N/A | SIT | 5.21 | N/A | Systems Integration Testing (SIT) | SITAG |  |  |  |  |  |  |
| 967 | 1.4.1.4.3.1 | **Test Approach & Plan** |  | 75d | 2023-09-07 A | 2023-12-20 A |  | 100% |  | 2023-09-07 | 2023-12-20 | 75d | 2023-09-07 | 2023-12-20 |  |  | -0 | N/A | N/A | SIT | 5.0 |  | Systems Integration Testing (SIT) | SITAG |  |  |  |  |  |  |
| 968 | 1.4.1.4.3.1.1 | Develop document with SITWG |  | 32d | 2023-09-07 A | 2023-10-20 A | 2534 | 100% |  | 2023-09-07 | 2023-10-20 | 25d | 2023-09-07 | 2023-10-11 |  | finish no earlier than 2023-10-11 |  | SI Test |  | SIT | 5.0 |  | Systems Integration Testing (SIT) | SITAG | Complete | COMPLETE |  |  |  |  |
| 969 | 1.4.1.4.3.1.2 | Draft document review with Code Bodies |  | 8d | 2023-10-23 A | 2023-11-01 A | 968 | 100% |  | 2023-10-23 | 2023-11-01 | 10d | 2023-10-12 | 2023-10-25 |  |  |  | SI Test | Code Bodies | SIT | 5.0 |  | Systems Integration Testing (SIT) | SITAG | Complete | COMPLETE |  |  |  |  |
| 970 | 1.4.1.4.3.1.3 | Industry Consultation |  | 10d | 2023-11-02 A | 2023-11-15 A | 969 | 100% |  | 2023-11-02 | 2023-11-15 | 10d |  |  |  |  |  | PP |  | SIT | 5.1 |  | Systems Integration Testing (SIT) | SITAG | Complete | COMPLETE |  |  |  |  |
| 971 | 1.4.1.4.3.1.4 | Artefact review (via TMAG) and updates |  | 25d | 2023-11-16 A | 2023-12-20 A | 970 | 100% |  | 2023-11-16 | 2023-12-20 | 30d | 2023-10-26 | 2023-12-20 |  |  |  | SI Test | PP,IPA,Code Bodies | SIT | 5.0 |  | Systems Integration Testing (SIT) | SITAG | Complete | COMPLETE |  |  |  |  |
| 972 | 1.4.1.4.3.1.5 | SIT Migration Testing Test Approach & Plan approved | milestone | 0d | 2023-12-20 A | 2023-12-20 A | 971 | 100% |  | 2023-12-20 | 2023-12-20 | 1d | 2023-12-20 | 2023-12-20 |  | finish no earlier than 2023-12-20 |  | SI Test | PP | SIT | 5.14 |  | Systems Integration Testing (SIT) | SITAG | Complete | COMPLETE | T3-TE-0018 | T3 | MHHS-ART073 |  |
| 973 | 1.4.1.4.3.2 | **Test Data Approach & Plan** |  | 35d | 2023-11-02 A | 2023-12-20 A |  | 100% |  | 2023-11-02 | 2023-12-20 | 35d | 2023-10-26 | 2023-12-20 |  |  | -0 | N/A | N/A | SIT | 5.0 | N/A | Systems Integration Testing (SIT) | SITAG |  |  |  |  |  |  |
| 974 | 1.4.1.4.3.2.1 | Industry Consultation |  | 10d | 2023-11-02 A | 2023-11-15 A | 970SS | 100% |  | 2023-11-02 | 2023-11-15 | 10d |  |  |  |  |  | PP |  | SIT | 5.1 | PP | Systems Integration Testing (SIT) | SITAG | Complete | COMPLETE |  |  |  |  |
| 975 | 1.4.1.4.3.2.2 | Artefact review (via TMAG) and updates |  | 25d | 2023-11-16 A | 2023-12-20 A | 974 | 100% |  | 2023-11-16 | 2023-12-20 | 30d | 2023-10-26 | 2023-12-20 |  |  |  | SI Test Data |  | SIT | 5.0 | Richard Puddephatt | Systems Integration Testing (SIT) | SITAG | Complete | COMPLETE |  |  |  |  |
| 976 | 1.4.1.4.3.2.3 | SIT Migration Test Data Test Approach & Plan approved | milestone | 0d | 2023-12-20 A | 2023-12-20 A | 975 | 100% |  | 2023-12-20 | 2023-12-20 | 0d | 2023-12-20 | 2023-12-20 |  |  |  | SI Test Data | PP,IPA | SIT | 5.14 | Richard Puddephatt | Systems Integration Testing (SIT) | SITAG | Complete | COMPLETE |  |  |  |  |
| 977 | 1.4.1.4.3.3 | **Test scenarios & Test Cases** |  | 292d? | 2023-12-21 A | 2025-01-31 |  | 74% | 75.26d? | 2023-12-21 | 2024-10-04 | 65d | 2023-07-24 | 2024-01-17 | 32327d |  | -0 | N/A | N/A | SIT | 5.16 | N/A | Systems Integration Testing (SIT) | SITAG |  |  |  |  |  |  |
| 978 | 1.4.1.4.3.3.1 | **Theme 1** |  | 65d | 2023-12-21 A | 2024-03-20 A |  | 100% |  | 2023-12-21 | 2024-03-20 | 65d |  |  |  |  | -0 | N/A | N/A | SIT | 5.16 | N/A | Systems Integration Testing (SIT) | SITAG |  |  |  |  |  | -448.67 |
| 979 | 1.4.1.4.3.3.1.1 | Develop Test Scenarios & Test Cases |  | 25d | 2023-12-21 A | 2024-01-24 A | 972 | 100% |  | 2023-12-21 | 2024-01-24 | 25d |  |  |  |  |  | SI Test | SI Test, PP | SIT | 5.16 |  |  | SITAG | Complete | COMPLETE |  |  |  |  |
| 980 | 1.4.1.4.3.3.1.2 | Industry Review Workshop |  | 1d | 2024-01-25 A | 2024-01-25 A | 979 | 100% |  | 2024-01-25 | 2024-01-25 | 1d |  |  |  |  |  | SI Test, PP | SI Test, PP | SIT | 5.16 |  |  | SITAG | Complete | COMPLETE |  |  |  |  |
| 981 | 1.4.1.4.3.3.1.3 | Industry Consultation Review |  | 6d | 2024-02-05 A | 2024-02-12 A | 980FS+6d | 100% |  | 2024-02-05 | 2024-02-12 | 6d |  |  |  |  |  | SI Test, PP | SI Test, PP | SIT | 5.16 |  |  | SITAG | Complete | COMPLETE |  |  |  |  |
| 982 | 1.4.1.4.3.3.1.4 | Review with SIT Working Group |  | 5d | 2024-02-29 A | 2024-03-06 A | 981FS+12d | 100% |  | 2024-02-29 | 2024-03-06 | 5d |  |  |  |  |  | SI Test, PP | SI Test, PP | SIT | 5.19 |  |  | SITAG | Complete | COMPLETE |  |  |  |  |
| 983 | 1.4.1.4.3.3.1.5 | SIT Migration Test scenarios & Test Cases Approved - Theme 1 | milestone | 0d | 2024-03-20 A | 2024-03-20 A | 982FS+10d | 100% |  | 2024-03-20 | 2024-03-20 | 0d |  |  |  |  |  | SI Test | SI Test, PP | SIT | 5.21 |  | Systems Integration Testing (SIT) | SITAG | Complete | COMPLETE | T3-TE-0110 | T3 |  |  |
| 984 | 1.4.1.4.3.3.2 | **Theme 2** |  | 85d | 2023-12-21 A | 2024-04-17 A |  | 100% |  | 2023-12-21 | 2024-04-17 | 85d |  |  |  |  | -0 | N/A | N/A | SIT | 5.16 | N/A | Systems Integration Testing (SIT) | SITAG |  |  |  |  |  | -448.67 |
| 985 | 1.4.1.4.3.3.2.1 | Develop Test Scenarios & Test Cases |  | 40d | 2023-12-21 A | 2024-02-14 A | 972 | 100% |  | 2023-12-21 | 2024-02-14 | 40d |  |  |  |  |  | SI Test | SI Test, PP | SIT | 5.16 |  |  | SITAG | Complete | COMPLETE |  |  |  |  |
| 986 | 1.4.1.4.3.3.2.2 | Industry Review Workshop |  | 1d | 2024-02-15 A | 2024-02-15 A | 985 | 100% |  | 2024-02-15 | 2024-02-15 | 1d |  |  |  |  |  | SI Test, PP | SI Test, PP | SIT | 5.16 |  |  | SITAG | Complete | COMPLETE |  |  |  |  |
| 987 | 1.4.1.4.3.3.2.3 | Industry Consultation Review |  | 6d | 2024-02-26 A | 2024-03-04 A | 986FS+6d | 100% |  | 2024-02-26 | 2024-03-04 | 6d |  |  |  |  |  | SI Test, PP | SI Test, PP | SIT | 5.19 |  |  | SITAG | Complete | COMPLETE |  |  |  |  |
| 988 | 1.4.1.4.3.3.2.4 | Review with SIT Working Group |  | 5d | 2024-03-28 A | 2024-04-03 A | 987FS+17d | 100% |  | 2024-03-28 | 2024-04-03 | 5d |  |  |  |  |  | SI Test, PP | SI Test, PP | SIT | 5.16 |  |  | SITAG | Complete | COMPLETE |  |  |  |  |
| 989 | 1.4.1.4.3.3.2.5 | SIT Migration Test scenarios & Test Cases Approved - Theme 2 | milestone | 0d | 2024-04-17 A | 2024-04-17 A | 988FS+10d | 100% |  | 2024-04-17 | 2024-04-17 | 0d |  |  |  |  |  | SI Test | SI Test, PP | SIT | 5.22 |  | Systems Integration Testing (SIT) | SITAG | Complete | COMPLETE | T3-TE-0111 | T3 |  |  |

| ID | WBS | Task | Type | Duration | Start | Finish | Predecessors | Complete | Remaining | Baseline start | Baseline finish | Baseline duration | Total slack | Free slack | Constraint | Baseline cost | Responsible | Involved | Text9 | Task Status | Update Version | MHHS Resource Name | MHHS Programme Phase | Text29 | Sched Status | RAG | Milestone ID | Tier |
| --- | --- | --- | --- | --- | --- | --- | --- | --- | --- | --- | --- | --- | --- | --- | --- | --- | --- | --- | --- | --- | --- | --- | --- | --- | --- | --- | --- | --- |
| 990 | 1.4.1.4.3.3.3 | **Theme 3** |  | 85d | 2023-12-21 A | 2024-04-17 A |  | 100% |  | 2023-12-21 | 2024-04-17 | 85d |  |  |  | -0 | N/A | N/A | SIT | -448.67 | 5.16 | N/A | Systems Integration Testing (SIT) | SITAG |  |  |  |  |
| 991 | 1.4.1.4.3.3.3.1 | Develop Test Scenarios & Test Cases |  | 55d | 2023-12-21 A | 2024-03-06 A | 972 | 100% |  | 2023-12-21 | 2024-03-06 | 55d |  |  |  |  | SI Test | SI Test, PP | SIT |  | 5.19 |  |  | SITAG | Complete | COMPLETE |  |  |
| 992 | 1.4.1.4.3.3.3.2 | Industry Review Workshop |  | 1d | 2024-03-07 A | 2024-03-07 A | 991 | 100% |  | 2024-03-07 | 2024-03-07 | 1d |  |  |  |  | SI Test, PP | SI Test, PP | SIT |  | 5.16 |  |  | SITAG | Complete | COMPLETE |  |  |
| 993 | 1.4.1.4.3.3.3.3 | Industry Consultation Review |  | 6d | 2024-03-13 A | 2024-03-20 A | 992FS+3d | 100% |  | 2024-03-13 | 2024-03-20 | 6d |  |  |  |  | SI Test, PP | SI Test, PP | SIT |  | 5.16 |  |  | SITAG | Complete | COMPLETE |  |  |
| 994 | 1.4.1.4.3.3.3.4 | Review with SIT Working Group |  | 5d | 2024-03-28 A | 2024-04-03 A | 993FS+5d | 100% |  | 2024-03-28 | 2024-04-03 | 5d |  |  |  |  | SI Test, PP | SI Test, PP | SIT |  | 5.16 |  |  | SITAG | Complete | COMPLETE |  |  |
| 995 | 1.4.1.4.3.3.3.5 | SIT Migration Test scenarios & Test Cases Approved - Theme 3 | milestone | 0d | 2024-04-17 A | 2024-04-17 A | 994FS+10d | 100% |  | 2024-04-17 | 2024-04-17 | 0d |  |  |  |  | SI Test | SI Test, PP | SIT |  | 5.22 |  | Systems Integration Testing (SIT) | SITAG | Complete | COMPLETE | T3-TE-0112 | T3 |
| 996 | 1.4.1.4.3.3.4 | **RTTM Development** |  | 27d? | 2024-08-29 A | 2024-10-04 |  | 84% | 4.38d? | 2024-08-29 | 2024-10-04 | 0d | 32412d |  |  |  | SI Test |  | SIT | -693.67 | 6.0 | Ankur Pande |  | SITAG | Overdue Start | GREEN |  |  |
| 997 | 1.4.1.4.3.3.4.1 | Develop Manual SIT Migration RTTM |  | 17d | 2024-08-29 A | 2024-09-20 A |  | 100% |  | 2024-08-29 | 2024-09-20 | 0d |  |  | start no earlier than 2024-08-29 |  | SI Test |  | SIT |  | 6.0 | Ankur Pande |  | SITAG | Complete | COMPLETE |  |  |
| 998 | 1.4.1.4.3.3.4.2 | Manual SIT Migration RTTM Complete | milestone | 0d | 2024-09-20 A | 2024-09-20 A | 997 | 100% |  | 2024-09-20 | 2024-09-20 | 0d |  |  |  |  | SI Test |  | SIT |  | 6.0 | Ankur Pande |  | SITAG | Complete | COMPLETE |  |  |
| 999 | 1.4.1.4.3.3.4.3 | Develop Automated SIT Migration RTTM |  | 20d | 2024-09-09 A | 2024-10-04 |  | 70% | 6d | 2024-09-09 | 2024-10-04 | 0d | 32412d | 0d | start no earlier than 2024-09-09 |  | SI Test |  | SIT |  | 6.0 | Ankur Pande |  | SITAG | Overdue | RED |  |  |
| 1000 | 1.4.1.4.3.3.4.4 | Automated SIT Migration RTTM Complete | milestone | 0d? | 2024-10-04 | 2024-10-04 | 999 |  |  | 2024-10-04 | 2024-10-04 | 0d | 32412d |  |  |  | SI Test |  | SIT | -76.29 | 6.0 | Ankur Pande |  | SITAG | Overdue Start | RED |  |  |
| 1001 | 1.4.1.4.3.3.5 | **Gap analysis** |  | 102d? | 2024-09-12 A | 2025-01-31 |  | 47% | 53.83d? | 2024-09-12 | 2024-10-04 | 0d | 32327d |  |  |  | SI Test |  | SIT | -693.67 | 6.0 | Ankur Pande |  | SITAG | Overdue Start | GREEN |  |  |
| 1002 | 1.4.1.4.3.3.5.1 | Identify gaps in test case coverage following RTTM review. |  | 12d | 2024-09-12 A | 2024-09-27 A | 997SS+10d | 100% |  | 2024-09-12 | 2024-09-27 | 0d |  |  |  |  | SI Test |  | SIT |  | 6.0 | Ankur Pande |  | SITAG | Complete | COMPLETE |  |  |
| 1003 | 1.4.1.4.3.3.5.2 | Address gaps in test case coverage following RTTM review. |  | 17d | 2024-09-19 A | 2024-10-11 A | 1002SS+5d | 100% |  | 2024-09-19 | 2024-10-04 | 0d |  |  |  |  | SI Test |  | SIT |  | 6.0 | Ankur Pande |  | SITAG | Complete | COMPLETE |  |  |
| 1004 | 1.4.1.4.3.3.5.3 | Gap analysis complete | milestone | 0d? | 2024-10-11 A | 2024-10-11 A | 1003 | 100% |  | 2024-10-04 | 2024-10-04 | 0d |  |  |  |  | SI Test |  | SIT |  | 6.0 | Ankur Pande |  | SITAG | Complete | COMPLETE |  |  |
| 1005 | 1.4.1.4.3.3.5.4 | Test Script updates identified |  | 1d? | 2024-10-14 A | 2024-10-14 A | 1004 | 100% |  | 2024-10-14 | 2024-10-14 | 0d |  |  |  |  | SI Test |  | SIT |  | 6.11 | Ankur Pande |  | SITAG | Complete | COMPLETE |  |  |
| 1006 | 1.4.1.4.3.3.5.5 | Test Scripts updates |  | 16d? | 2024-10-14 A | 2024-11-04 A | 1005FS-1d | 100% |  | 2024-10-14 | 2024-11-04 | 0d |  |  |  |  | SI Test |  | SIT |  | 6.11 | Ankur Pande |  | SITAG | Complete | COMPLETE |  |  |
| 1007 | 1.4.1.4.3.3.5.6 | RTTM Updated |  | 1d? | 2024-10-29 A | 2024-10-29 A | 1006FS-5d | 100% |  | 2024-10-29 | 2024-10-29 | 0d |  |  |  |  | SI Test |  | SIT |  | 6.11 | Ankur Pande |  | SITAG | Complete | COMPLETE |  |  |
| 1008 | 1.4.1.4.3.3.5.7 | Removal of de-scoped TCs from the RTTMs |  | 2d | 2024-10-31 A | 2024-11-01 A | 1006FS-3d | 100% |  | 2024-10-31 | 2024-11-01 | 0d |  |  |  |  | SI Test |  | SIT |  | 6.11 | Ankur Pande |  | SITAG | Complete | COMPLETE |  |  |
| 1009 | 1.4.1.4.3.3.5.8 | Update and stabilisation of all TC ADO IDs |  | 2d | 2024-10-31 A | 2024-11-01 A | 1006FS-3d | 100% |  | 2024-10-31 | 2024-11-01 | 0d |  |  |  |  | SI Test |  | SIT |  | 6.11 | Ankur Pande |  | SITAG | Complete | COMPLETE |  |  |
| 1010 | 1.4.1.4.3.3.5.9 | Addition and integration of Role tags to reqs in the Role RTTMs |  | 3d | 2024-10-30 A | 2024-11-01 A | 1006FS-4d | 100% |  | 2024-10-30 | 2024-11-01 | 0d |  |  |  |  | SI Test |  | SIT |  | 6.11 | Ankur Pande |  | SITAG | Complete | COMPLETE |  |  |
| 1011 | 1.4.1.4.3.3.5.10 | Update of the RTTM All sheet (porting of the individual RTTMs) |  | 2d | 2024-10-31 A | 2024-11-01 A | 1006FS-3d | 100% |  | 2024-10-31 | 2024-11-01 | 0d |  |  |  |  | SI Test |  | SIT |  | 6.11 | Ankur Pande |  | SITAG | Complete | COMPLETE |  |  |
| 1012 | 1.4.1.4.3.3.5.11 | ADO IDs corrected |  | 1d? | 2024-11-04 A | 2024-11-04 A | 1011 | 100% |  | 2024-11-04 | 2024-11-04 | 0d |  |  | start no earlier than 2024-10-16 |  | SI Test |  | SIT |  | 6.11 | Ankur Pande |  | SITAG | Complete | COMPLETE |  |  |
| 1013 | 1.4.1.4.3.3.5.12 | Migration RTTM ready for import into ADO | milestone | 0d | 2024-11-04 A | 2024-11-04 A | 1012 | 100% |  | 2024-11-04 | 2024-11-04 | 0d |  |  |  |  | SI Test |  | SIT |  | 6.11 | Ankur Pande |  | SITAG | Complete | COMPLETE |  |  |
| 1014 | 1.4.1.4.3.3.5.13 | Issue Static RTTM to Code Bodies |  | 1d? | 2024-11-05 A | 2024-11-05 A | 1013 | 100% |  | 2024-11-05 | 2024-11-05 | 0d |  |  |  |  | SI Test |  | SIT |  | 6.11 | Ankur Pande |  | SITAG | Complete | COMPLETE |  |  |
| 1015 | 1.4.1.4.3.3.5.14 | Implement Code Bodies feedback on RTTM |  | 6d | 2024-11-06 A | 2024-11-13 A | 1014 | 100% |  | 2024-11-06 | 2024-11-13 | 0d |  |  |  |  | SI Test |  | SIT |  | 6.12 | Ankur Pande |  | SITAG | Complete | COMPLETE |  |  |
| 1016 | 1.4.1.4.3.3.5.15 | Code Body Acceptance of RTTM | milestone | 0d | 2024-11-13 A | 2024-11-13 A | 1014, 1015 | 100% |  | 2024-11-06 | 2024-11-13 | 0d |  |  |  |  | SI Test |  | SIT |  | 6.11 | Ankur Pande |  | SITAG | Complete | COMPLETE |  |  |

Notes:
- 999: 18/12/24 - Programme and SRO still agreeing a definition of the automated RTTM, action can't be completed until this is done.
- 1000: 18/12/24 - Programme and SRO still agreeing a definition of the automated RTTM, action can't be completed until this is done.

| ID | WBS | Task | Type | Duration | Start | Finish | Predecessors | Complete | Remaining | Actual start | Baseline start | Baseline finish | Baseline duration | Total slack | Free slack | Constraint | Text9 | Task Status | Update Version | Sched Status | MHHS Resource Name | Text29 | RAG | Responsible | Milestone ID | Tier |
| --- | --- | --- | --- | --- | --- | --- | --- | --- | --- | --- | --- | --- | --- | --- | --- | --- | --- | --- | --- | --- | --- | --- | --- | --- | --- | --- |
| 1017 | 1.4.1.4.3.3.5.16 | **ADO Clean-up** |  | 17d? | 2024-10-24 | 2024-11-15 A |  | 100% |  | 2024-10-25 | 2024-10-24 | 2024-11-15 | 0d |  |  |  | SIT | -727.67 | 6.11 | Overdue Start | Heath Thomas | SITAG |  |  |  |  |
| 1018 | 1.4.1.4.3.3.5.16.1 | Theme alignment |  | 1d? | 2024-10-28 A | 2024-10-28 A |  | 100% |  |  | 2024-10-28 | 2024-10-28 | 0d |  |  | start no earlier than 2024-10-28 | SIT |  | 6.11 | Complete | Heath Thomas | SITAG | COMPLETE |  |  |  |
| 1019 | 1.4.1.4.3.3.5.16.2 | Understand Additional suffix Fields in ADO as defined by Kevin |  | 1d? | 2024-10-25 A | 2024-10-25 A |  | 100% |  |  | 2024-10-25 | 2024-10-25 | 0d |  |  | finish no earlier than 2024-10-25 | SIT |  | 6.11 | Complete | Heath Thomas | SITAG | COMPLETE |  |  |  |
| 1020 | 1.4.1.4.3.3.5.16.3 | Correct Missing Test Case References |  | 1d? | 2024-10-28 A | 2024-10-28 A |  | 100% |  |  | 2024-10-28 | 2024-10-28 | 0d |  |  | start no earlier than 2024-10-28 | SIT |  | 6.11 | Complete | Heath Thomas | SITAG | COMPLETE |  |  |  |
| 1021 | 1.4.1.4.3.3.5.16.4 | Load Functional RTTMs into ADO |  | 1d? | 2024-10-28 A | 2024-10-28 A |  | 100% |  |  | 2024-10-28 | 2024-10-28 | 0d |  |  | start no earlier than 2024-10-28 | SIT |  | 6.11 | Complete | Heath Thomas | SITAG | COMPLETE |  |  |  |
| 1022 | 1.4.1.4.3.3.5.16.5 | Load Migration RTTMs into ADO |  | 1d? | 2024-11-06 A | 2024-11-06 A |  | 100% |  |  | 2024-11-06 | 2024-11-06 | 0d |  |  | start no earlier than 2024-11-06 | SIT |  | 6.11 | Complete | Heath Thomas | SITAG | COMPLETE |  |  |  |
| 1023 | 1.4.1.4.3.3.5.16.6 | Confirm Missing fields in ADO are resolved |  | 1d? | 2024-11-07 A | 2024-11-07 A |  | 100% |  |  | 2024-11-07 | 2024-11-07 | 0d |  |  | finish no earlier than 2024-11-07 | SIT |  | 6.11 | Complete | Heath Thomas | SITAG | COMPLETE |  |  |  |
| 1024 | 1.4.1.4.3.3.5.16.7 | Reload Functional RTTM into ADO |  | 1d? | 2024-11-07 A | 2024-11-07 A |  | 100% |  |  | 2024-11-07 | 2024-11-07 | 0d |  |  | start no earlier than 2024-11-07 | SIT |  | 6.11 | Complete | Heath Thomas | SITAG | COMPLETE |  |  |  |
| 1025 | 1.4.1.4.3.3.5.16.8 | **ADO Design Documentation** |  | 10d? | 2024-11-04 | 2024-11-15 A |  | 100% |  | 2024-11-15 | 2024-11-04 | 2024-11-15 | 0d |  |  |  | SIT | -727.67 | 6.11 | Overdue Start | Heath Thomas | SITAG |  |  |  |  |
| 1026 | 1.4.1.4.3.3.5.16.8.1 | Produce ADO high Level Design and Data Model |  | 1d? | 2024-11-15 A | 2024-11-15 A |  | 100% |  |  | 2024-11-15 | 2024-11-15 | 0d |  |  | finish no earlier than 2024-11-15 | SIT |  | 6.11 | Complete | Heath Thomas | SITAG | COMPLETE |  |  |  |
| 1027 | 1.4.1.4.3.3.5.16.8.2 | Produce Report derivation document |  | 1d? | 2024-11-15 A | 2024-11-15 A |  | 100% |  |  | 2024-11-15 | 2024-11-15 | 0d |  |  | finish no earlier than 2024-11-15 | SIT |  | 6.11 | Complete | Heath Thomas | SITAG | COMPLETE |  |  |  |
| 1028 | 1.4.1.4.3.3.5.17 | **Test Case Rationalisation (Fuctional + Migration)** |  | 62d | 2024-11-07 A | 2025-01-31 |  | 4% | 59.56d |  | 2024-11-07 | 2024-12-20 | 0d | 32327d |  |  | SIT | -727.67 | 6.11 | Overdue Start | Roger Robar | SITAG | RED |  |  |  |
| 1029 | 1.4.1.4.3.3.5.17.1 | Internal preliminary rationalisation workshop 1 |  | 1d | 2024-11-07 A | 2024-11-07 A | 1014FS+1d | 100% |  |  | 2024-11-07 | 2024-11-07 | 0d |  |  |  | SIT |  | 6.11 | Complete | Roger Robar | SITAG | COMPLETE |  |  |  |
| 1030 | 1.4.1.4.3.3.5.17.2 | Baseline RTTMs | milestone | 0d | 2024-11-13 A | 2024-11-13 | 1016, 882 | 90% | 0d |  | 2024-11-13 | 2024-11-13 | 0d | 32384d |  |  | SIT |  | 6.11 | Green | Roger Robar | SITAG | RED |  |  |  |
| 1031 | 1.4.1.4.3.3.5.17.3 | Baseline test cases | milestone | 0d | 2024-11-13 A | 2024-11-13 A | 1016 | 100% |  |  | 2024-11-13 | 2024-11-13 | 0d |  |  |  | SIT |  | 6.11 | Complete | Roger Robar | SITAG | COMPLETE |  |  |  |
| 1032 | 1.4.1.4.3.3.5.17.4 | Produce requirements / test case analysis |  | 1d | 2024-11-14 A | 2024-11-14 A | 1031 | 100% |  |  | 2024-11-14 | 2024-11-14 | 0d |  |  |  | SIT |  | 6.11 | Complete | Roger Robar | SITAG | COMPLETE |  |  |  |
| 1033 | 1.4.1.4.3.3.5.17.5 | Internal finalisation rationalisation workshop 2 |  | 13d | 2024-11-15 A | 2024-12-03 | 1032 | 4% | 12.5d |  | 2024-11-15 | 2024-11-15 | 0d | 32369d | 0d |  | SIT |  | 6.14 | Red | Roger Robar | SITAG | RED |  |  |  |
| 1034 | 1.4.1.4.3.3.5.17.6 | SRO walkthrough |  | 1d | 2024-12-04 | 2024-12-04 | 1033 |  |  |  | 2024-11-21 | 2024-11-21 | 0d | 32369d |  |  | SIT | -15.67 | 6.14 | yellow | Roger Robar | SITAG | RED |  |  |  |
| 1035 | 1.4.1.4.3.3.5.17.7 | Code Bodies walkthrough |  | 1d | 2024-12-04 | 2024-12-04 | 1033 |  |  |  | 2024-11-26 | 2024-11-26 | 0d | 32369d |  |  | SIT | -15.67 | 6.14 | yellow | Roger Robar | SITAG | RED |  |  |  |
| 1036 | 1.4.1.4.3.3.5.17.8 | Send invites to PPs for walkthrough |  | 1d | 2024-12-04 A | 2024-12-04 A | 1035FS-1d | 100% |  |  | 2024-11-26 | 2024-11-26 | 0d |  |  |  | SIT |  | 6.14 | Complete | Roger Robar | SITAG | COMPLETE |  |  |  |
| 1037 | 1.4.1.4.3.3.5.17.9 | PP walkthrough |  | 1d | 2024-12-17 | 2024-12-17 | 1036FS+8d |  |  |  | 2024-12-03 | 2024-12-03 | 0d | 32327d | 0d |  | SIT | -2.67 | 6.14 | Red | Roger Robar | SITAG | RED |  |  |  |
| 1038 | 1.4.1.4.3.3.5.17.10 | Update test cases |  | 20d | 2024-12-18 | 2025-01-14 | 1037 |  |  |  | 2024-12-04 | 2024-12-10 | 0d | 32333d | 6d |  | SIT | -1.67 | 6.14 | Red | Roger Robar | SITAG | RED |  |  |  |
| 1039 | 1.4.1.4.3.3.5.17.11 | Update RTTM |  | 20d | 2024-12-18 | 2025-01-14 | 1037 |  |  |  | 2024-12-04 | 2024-12-10 | 0d | 32340d |  |  | SIT | -1.67 | 6.14 | Red | Roger Robar | SITAG | RED |  |  |  |
| 1040 | 1.4.1.4.3.3.5.17.12 | Update master test case spreadsheet |  | 20d | 2024-12-18 | 2025-01-14 | 1037 |  |  |  | 2024-12-04 | 2024-12-10 | 0d | 32327d | 0d |  | SIT | -1.67 | 6.14 | Red | Roger Robar | SITAG | RED |  |  |  |
| 1041 | 1.4.1.4.3.3.5.17.13 | SITWG Paper Day | milestone | 0d | 2025-01-14 | 2025-01-14 | 1040 |  |  |  | 2024-12-20 | 2024-12-20 | 0d | 32327d | 0d |  | SIT | 25.71 | 6.14 | Red |  | SITAG | RED |  |  |  |
| 1042 | 1.4.1.4.3.3.5.17.14 | SITWG recommendation | milestone | 0d | 2025-01-21 | 2025-01-21 | 1041FS+5d |  |  |  | 2025-01-08 | 2025-01-08 | 0d | 32327d | 0d |  | SIT | 32.71 | 6.14 | yellow |  | SITAG | RED |  |  |  |
| 1043 | 1.4.1.4.3.3.5.17.15 | Issue to SITAG / SITAG paper day | milestone | 0d | 2025-01-22 | 2025-01-22 | 1038, 1042FS+1d |  |  |  | 2024-12-11 | 2024-12-11 | 0d | 32327d | 0d |  | SIT | 33.71 | 6.14 | Red | Roger Robar | SITAG | RED |  |  |  |
| 1044 | 1.4.1.4.3.3.5.17.16 | Prepare ADO update |  | 6d | 2025-01-15 | 2025-01-22 | 1040 |  |  |  | 2024-12-11 | 2024-12-18 | 0d | 32334d |  |  | SIT | 26.33 | 6.14 | Red | Roger Robar | SITAG | RED |  |  |  |
| 1045 | 1.4.1.4.3.3.5.17.17 | Sign off by SITAG | milestone | 0d | 2025-01-29 | 2025-01-29 | 1043FS+5d |  |  |  | 2024-12-18 | 2024-12-18 | 0d | 32327d | 0d |  | SIT | 40.71 | 6.14 | Red | Roger Robar | SITAG | RED |  |  |  |
| 1046 | 1.4.1.4.3.3.5.17.18 | Update ADO |  | 2d | 2025-01-30 | 2025-01-31 | 1045 |  |  |  | 2024-12-19 | 2024-12-20 | 0d | 32327d | 0d |  | SIT | 41.33 | 6.14 | Red | Roger Robar | SITAG | RED |  |  |  |
| 1047 | 1.4.1.4.3.3.5.17.19 | Update all ADO reporting |  | 2d | 2025-01-30 | 2025-01-31 | 1045 |  |  |  | 2024-12-19 | 2024-12-20 | 0d | 32327d | 0d |  | SIT | 41.33 | 6.14 | Red | Roger Robar | SITAG | RED |  |  |  |
| 1048 | 1.4.1.4.3.3.5.17.20 | Test Case Rationalisation complete | milestone | 0d | 2025-01-31 | 2025-01-31 | 1046, 1047 |  |  |  | 2024-12-20 | 2024-12-20 | 0d | 32327d |  |  | SIT | 42.71 | 6.14 | Red | Roger Robar | SITAG | RED | SI Test | T3-TE-0141 | T3 |

Notes:
- 1029: 18/12/24 - Programme walked through the proposed updates to Rationalisation plan at Dec SITAG. Due to return to Jan SITAG to formally approve and rebaseline this date.
- 1030: 18/12/24 - Programme walked through the proposed updates to Rationalisation plan at Dec SITAG. Due to return to Jan SITAG to formally approve and rebaseline this date.
- 1031: 18/12/24 - Programme walked through the proposed updates to Rationalisation plan at Dec SITAG. Due to return to Jan SITAG to formally approve and rebaseline this date.
- 1032: 18/12/24 - Programme walked through the proposed updates to Rationalisation plan at Dec SITAG. Due to return to Jan SITAG to formally approve and rebaseline this date.
- 1033: 18/12/24 - Programme walked through the proposed updates to Rationalisation plan at Dec SITAG. Due to return to Jan SITAG to formally approve and rebaseline this date.
- 1034: 18/12/24 - Programme walked through the proposed updates to Rationalisation plan at Dec SITAG. Due to return to Jan SITAG to formally approve and rebaseline this date.
- 1035: 18/12/24 - Programme walked through the proposed updates to Rationalisation plan at Dec SITAG. Due to return to Jan SITAG to formally approve and rebaseline this date.
- 1036: 18/12/24 - Programme walked through the proposed updates to Rationalisation plan at Dec SITAG. Due to return to Jan SITAG to formally approve and rebaseline this date.
- 1037: 18/12/24 - Programme walked through the proposed updates to Rationalisation plan at Dec SITAG. Due to return to Jan SITAG to formally approve and rebaseline this date.
- 1038: 18/12/24 - Programme walked through the proposed updates to Rationalisation plan at Dec SITAG. Due to return to Jan SITAG to formally approve and rebaseline this date.
- 1039: 18/12/24 - Programme walked through the proposed updates to Rationalisation plan at Dec SITAG. Due to return to Jan SITAG to formally approve and rebaseline this date.
- 1040: 18/12/24 - Programme walked through the proposed updates to Rationalisation plan at Dec SITAG. Due to return to Jan SITAG to formally approve and rebaseline this date.
- 1041: 18/12/24 - Programme walked through the proposed updates to Rationalisation plan at Dec SITAG. Due to return to Jan SITAG to formally approve and rebaseline this date.
- 1042: 18/12/24 - Programme walked through the proposed updates to Rationalisation plan at Dec SITAG. Due to return to Jan SITAG to formally approve and rebaseline this date.
- 1043: 18/12/24 - Programme walked through the proposed updates to Rationalisation plan at Dec SITAG. Due to return to Jan SITAG to formally approve and rebaseline this date.
- 1044: 18/12/24 - Programme walked through the proposed updates to Rationalisation plan at Dec SITAG. Due to return to Jan SITAG to formally approve and rebaseline this date.
- 1045: 18/12/24 - Programme walked through the proposed updates to Rationalisation plan at Dec SITAG. Due to return to Jan SITAG to formally approve and rebaseline this date.
- 1046: 18/12/24 - Programme walked through the proposed updates to Rationalisation plan at Dec SITAG. Due to return to Jan SITAG to formally approve and rebaseline this date.
- 1047: 18/12/24 - Programme walked through the proposed updates to Rationalisation plan at Dec SITAG. Due to return to Jan SITAG to formally approve and rebaseline this date.
- 1048: 18/12/24 - Programme walked through the proposed updates to Rationalisation plan at Dec SITAG. Due to return to Jan SITAG to formally approve and rebaseline this date.

| ID | WBS | Task | Type | Duration | Start | Finish | Predecessors | Complete | Remaining | Baseline start | Baseline finish | Baseline duration | Baseline 1 start | Baseline 1 finish | Total slack | Constraint | Baseline cost | Responsible | Involved | Text9 | Update Version | MHHS Resource Name | MHHS Programme Phase | Text29 | Sched Status | RAG | Milestone ID | Tier | Artefact ID | Guidance |
| --- | --- | --- | --- | --- | --- | --- | --- | --- | --- | --- | --- | --- | --- | --- | --- | --- | --- | --- | --- | --- | --- | --- | --- | --- | --- | --- | --- | --- | --- | --- |
| 1049 | 1.4.1.4.3.4 | **Environments (SIT B)** |  | 435d | 2022-10-31 A | 2024-06-28 A |  | 100% |  | 2022-10-31 | 2024-06-28 | 420d | 2022-11-16 | 2024-05-13 |  |  | -0 | N/A | N/A | SIT | 5.0 | N/A | Systems Integration Testing (SIT) | SITAG |  |  |  |  |  |  |
| 1050 | 1.4.1.4.3.4.1 | **PP Environments (SIT B)** |  | 41d | 2024-05-03 A | 2024-06-28 A |  | 100% |  | 2024-05-03 | 2024-06-28 | 26d | 2022-11-16 | 2024-05-13 |  |  | -0 | N/A | N/A | SIT | 5.0 | N/A | Systems Integration Testing (SIT) | SITAG |  |  |  |  |  |  |
| 1051 | 1.4.1.4.3.4.1.1 | PP Environments available | milestone | 0d | 2024-05-03 A | 2024-05-03 A | 517 | 100% |  | 2024-05-03 | 2024-05-03 | 0d | 2022-11-16 | 2024-04-01 |  | start no earlier than 2024-05-03 |  | PP | SI Test | SIT | 5.21 | Simon Berry | Systems Integration Testing (SIT) | SITAG | Complete | COMPLETE |  |  |  |  |
| 1052 | 1.4.1.4.3.4.1.2 | PP Onboarding / Smoke test |  | 35d | 2024-05-13 A | 2024-06-28 A | 1051FS+6d | 100% |  | 2024-05-13 | 2024-06-28 | 20d | 2022-11-16 | 2024-04-01 |  |  |  | PP | SI Test | SIT | 5.21 | Simon Berry | Systems Integration Testing (SIT) | SITAG | Complete | COMPLETE |  |  |  |  |
| 1053 | 1.4.1.4.3.4.1.3 | DTN Connectivity Proving Complete |  | 5d | 2024-06-10 A | 2024-06-14 A | 1051FS+26d | 100% |  | 2024-06-10 | 2024-06-14 | 0d | 2024-04-15 | 2024-04-26 |  |  |  | PP | SI Test | SIT | 5.21 | Simon Berry | Systems Integration Testing (SIT) | SITAG | Complete | COMPLETE |  |  |  |  |
| 1054 | 1.4.1.4.3.4.1.4 | PP Code Deployment | milestone | 0d | 2024-06-14 A | 2024-06-14 A | 1053 | 100% |  | 2024-06-14 | 2024-06-14 | 0d | 2024-04-29 | 2024-05-13 |  |  |  | PP | SI Test | SIT | 5.21 | Simon Berry | Systems Integration Testing (SIT) | SITAG | Complete | COMPLETE |  |  |  |  |
| 1055 | 1.4.1.4.3.4.2 | **SI Environments (SIT B)** |  | 425d | 2022-10-31 A | 2024-06-14 A |  | 100% |  | 2022-10-31 | 2024-06-14 | 420d | 2022-11-16 | 2024-05-10 |  |  | -0 | N/A | N/A | SIT | 5.0 | N/A | Systems Integration Testing (SIT) | SITAG |  |  |  |  |  |  |
| 1056 | 1.4.1.4.3.4.2.1 | Coordinate SIT Participants' SIT B environment preparation |  | 420d | 2022-10-31 A | 2024-06-07 A |  | 100% |  | 2022-10-31 | 2024-06-07 | 420d | 2022-11-16 | 2024-04-01 |  |  |  | SI Test | PP | SIT | 5.21 | Simon Berry | Systems Integration Testing (SIT) | SITAG | Complete | COMPLETE |  |  |  |  |
| 1057 | 1.4.1.4.3.4.2.2 | Assure PPs' self-declaration of environment preparation complete (incl. security certificates and security compliance) | milestone | 0d | 2024-06-07 A | 2024-06-07 A | 1056 | 100% |  | 2024-06-07 | 2024-06-07 | 0d | 2022-11-16 | 2024-03-29 |  |  |  | SI Test | PP | SIT | 5.21 | Simon Berry | Systems Integration Testing (SIT) | SITAG | Complete | COMPLETE |  |  |  |  |
| 1058 | 1.4.1.4.3.4.2.3 | SIT Participants' SIT B environments ready to start connectivity proving (incl. certificates and security compliance) | milestone | 0d | 2024-06-05 A | 2024-06-05 A | 1051FS+24d | 100% |  | 2024-06-05 | 2024-06-05 | 0d | 2024-04-01 | 2024-04-01 |  |  |  | SI Test | PP,IPA | SIT | 5.26 | Simon Berry | Systems Integration Testing (SIT) | SITAG | Complete | COMPLETE | T3-TE-0033 | T3 |  |  |
| 1059 | 1.4.1.4.3.4.2.4 | Coordinate SIT Participants' SIT B environment connectivity proving |  | 2d | 2024-06-06 A | 2024-06-07 A | 1058 | 100% |  | 2024-06-06 | 2024-06-07 | 19d | 2024-04-01 | 2024-04-26 |  |  |  | SI Test | PP | SIT | 5.21 | Simon Berry | Systems Integration Testing (SIT) | SITAG | Complete | COMPLETE |  |  |  |  |
| 1060 | 1.4.1.4.3.4.2.5 | Coordinate deployment of MHHS solution code to SIT Participants' SIT B environments | milestone | 0d | 2024-06-14 A | 2024-06-14 A | 1054 | 100% |  | 2024-06-14 | 2024-06-14 | 4d | 2024-04-15 | 2024-04-26 |  |  |  | SI Test | PP | SIT | 5.21 | Simon Berry | Systems Integration Testing (SIT) | SITAG | Complete | COMPLETE |  |  |  |  |
| 1061 | 1.4.1.4.3.5 | **SIT Migration Test Readiness Report** |  | 44d | 2024-04-02 A | 2024-05-31 A |  | 100% |  | 2024-04-02 | 2024-05-31 | 44d | 2024-04-02 | 2024-05-27 |  |  | -0 | N/A | N/A | SIT | 5.0 | N/A | Systems Integration Testing (SIT) | SITAG |  |  |  |  |  |  |
| 1062 | 1.4.1.4.3.5.1 | **PP SIT Migration Test Readiness Report** |  | 44d | 2024-04-02 A | 2024-05-31 A |  | 100% |  | 2024-04-02 | 2024-05-31 | 44d | 2024-04-02 | 2024-05-13 |  |  | -0 | N/A | N/A | SIT | 5.0 | N/A | Systems Integration Testing (SIT) | SITAG |  |  |  |  |  |  |
| 1063 | 1.4.1.4.3.5.1.1 | Develop draft Test Readiness Report and submit to Programme for assurance |  | 20d | 2024-04-02 A | 2024-04-29 A |  | 100% |  | 2024-04-02 | 2024-04-29 | 20d | 2024-04-02 | 2024-04-30 |  | start no earlier than 2024-04-02 |  | PP | SI Test | SIT | 5.0 |  | Systems Integration Testing (SIT) | SITAG | Complete | COMPLETE |  |  |  |  |
| 1064 | 1.4.1.4.3.5.1.2 | Placing Reliance Stage 2 Review |  | 35d | 2024-04-15 A | 2024-05-31 A | 1063SS+9d | 100% |  | 2024-04-15 | 2024-05-31 | 35d |  |  |  |  |  | SI Test | PP | SIT | 5.12 |  | Systems Integration Testing (SIT) | SITAG | Complete | COMPLETE |  |  |  |  |
| 1065 | 1.4.1.4.3.5.1.3 | Finalise Test Readiness Report and submit to Programme for assurance |  | 10d | 2024-04-30 A | 2024-05-13 A | 1063 | 100% |  | 2024-04-30 | 2024-05-13 | 10d | 2024-04-30 | 2024-05-13 |  |  |  | PP | SI Test | SIT | 5.0 |  | Systems Integration Testing (SIT) | SITAG | Complete | COMPLETE |  |  |  |  |
| 1066 | 1.4.1.4.3.5.2 | **SI SIT Migration Test Readiness Report** |  | 40d | 2024-04-02 A | 2024-05-27 A |  | 100% |  | 2024-04-02 | 2024-05-27 | 40d | 2024-04-02 | 2024-05-27 |  |  |  | N/A | N/A | SIT | 5.0 | N/A | Systems Integration Testing (SIT) | SITAG |  |  |  |  |  |  |
| 1067 | 1.4.1.4.3.5.2.1 | Assure Test Participants' Test Readiness Reports |  | 35d | 2024-04-02 A | 2024-05-20 A | 1063SS, 1065FF+5d | 100% |  | 2024-04-02 | 2024-05-20 | 35d | 2024-04-02 | 2024-05-20 |  |  |  | SI Test | PP,IPA | SIT | 5.0 |  | Systems Integration Testing (SIT) | SITAG | Complete | COMPLETE |  |  |  |  |
| 1068 | 1.4.1.4.3.5.2.2 | Develop Overarching SIT Migration Test Readiness Report |  | 20d | 2024-04-23 A | 2024-05-20 A | 1067FF | 100% |  | 2024-04-23 | 2024-05-20 | 20d | 2024-04-23 | 2024-05-20 |  |  |  | SI Test |  | SIT | 5.0 |  | Systems Integration Testing (SIT) | SITAG | Complete | COMPLETE |  |  |  |  |
| 1069 | 1.4.1.4.3.5.2.3 | Artefact review (via SITAG) and updates |  | 5d | 2024-05-21 A | 2024-05-27 A | 1068 | 100% |  | 2024-05-21 | 2024-05-27 | 5d | 2024-05-21 | 2024-05-27 |  |  |  | SI Test | PP,IPA | SIT | 5.0 |  | Systems Integration Testing (SIT) | SITAG | Complete | COMPLETE |  |  |  |  |
| 1070 | 1.4.1.4.3.6 | SIT Migration Testing Preparation Complete | milestone | 0d | 2024-06-03 A | 2024-06-03 A | 1069FF+5d, 972, 380, 1064, 983, 989, 995 | 100% |  | 2024-06-03 | 2024-06-03 | 0d | 2024-06-03 | 2024-06-03 |  |  |  | SI Test | PP,IPA | SIT | 5.0 |  | Systems Integration Testing (SIT) | SITAG | Complete | COMPLETE | T2-TE-0650 | T2 |  |  |
| 1071 | 1.4.1.4.4 | **SIT Non-Functional Preparation** |  | 347d? | 2023-11-30 A | 2025-03-28 |  | 66% | 116.32d? | 2023-11-30 | 2025-03-14 | 193d | 2023-07-03 | 2024-08-26 | 32287d |  | -0 | N/A | N/A | SIT | 5.0 | N/A | Systems Integration Testing (SIT) | SITAG |  |  |  |  |  |  |
| 1072 | 1.4.1.4.4.1 | **Test Approach & Plan** |  | 120d | 2023-11-30 A | 2024-05-15 A |  | 100% |  | 2023-11-30 | 2024-05-15 | 120d | 2023-11-30 | 2024-03-20 |  |  | -0 | N/A | N/A | SIT | 5.0 | N/A | Systems Integration Testing (SIT) | SITAG |  |  |  |  |  |  |
| 1073 | 1.4.1.4.4.1.1 | Develop document with SITWG |  | 67d | 2023-11-30 A | 2024-03-01 A |  | 100% |  | 2023-11-30 | 2024-03-01 | 67d | 2023-11-30 | 2024-01-10 |  | must start on 2023-11-30 |  | SI Test |  | SIT | 5.0 |  | Systems Integration Testing (SIT) | SITAG | Complete | COMPLETE |  |  |  |  |
| 1074 | 1.4.1.4.4.1.2 | Draft document review with Code Bodies |  | 10d | 2024-03-04 A | 2024-03-15 A | 1073 | 100% |  | 2024-03-04 | 2024-03-15 | 10d | 2024-01-11 | 2024-01-24 |  |  |  | SI Test | Code Bodies | SIT | 5.0 |  | Systems Integration Testing (SIT) | SITAG | Complete | COMPLETE |  |  |  |  |
| 1075 | 1.4.1.4.4.1.3 | Industry Consultation |  | 10d | 2024-03-18 A | 2024-03-29 A | 1074 | 100% |  | 2024-03-18 | 2024-03-29 | 10d |  |  |  |  |  | PP |  | SIT | 5.1 |  | Systems Integration Testing (SIT) | SITAG | Complete | COMPLETE |  |  |  |  |
| 1076 | 1.4.1.4.4.1.4 | Industry Assurance Review |  | 5d | 2024-04-11 A | 2024-04-17 A | 1075FS+8d | 100% |  | 2024-04-11 | 2024-04-17 | 5d |  |  |  |  |  |  |  | SIT | 5.16 |  |  | SITAG | Complete | COMPLETE |  |  |  |  |
| 1077 | 1.4.1.4.4.1.5 | SIT Non-Functional Testing Test Approach & Plan approved | milestone | 0d | 2024-05-15 A | 2024-05-15 A | 1076FS+20d | 100% |  | 2024-05-15 | 2024-05-15 | 0d | 2024-03-20 | 2024-03-20 |  |  |  | SI Test | PP | SIT | 5.30 | Roger Robar | Systems Integration Testing (SIT) | SITAG | Complete | COMPLETE | T3-TE-0026 | T3 | MHHS-ART073 | 30/7/24: Approved at esitag on 26/7/24 |

| ID | WBS | Task | Type | Duration | Start | Finish | Predecessors | Complete | Remaining | Actual finish | Baseline start | Baseline finish | Baseline duration | Baseline 1 start | Baseline 1 finish | Total slack | Free slack | Constraint | Baseline cost | Responsible | Involved | Text9 | Update Version | MHHS Resource Name | MHHS Programme Phase | Text29 | Sched Status | RAG | Milestone ID | Tier | Task Status | Guidance |
| --- | --- | --- | --- | --- | --- | --- | --- | --- | --- | --- | --- | --- | --- | --- | --- | --- | --- | --- | --- | --- | --- | --- | --- | --- | --- | --- | --- | --- | --- | --- | --- | --- |
| 1078 | 1.4.1.4.4.2 | **Test Data Approach & Plan** |  | 41d | 2024-03-20 A | 2024-05-15 A |  | 100% |  |  | 2024-03-20 | 2024-05-15 | 41d | 2024-01-25 | 2024-03-20 |  |  |  | -0 | N/A | N/A | SIT | 5.0 | N/A | Systems Integration Testing (SIT) | SITAG |  |  |  |  |  |  |
| 1079 | 1.4.1.4.4.2.1 | Industry Consultation |  | 14d | 2024-03-20 A | 2024-04-08 A | 1075SS+2d | 100% |  |  | 2024-03-20 | 2024-04-08 | 14d |  |  |  |  |  |  | PP |  | SIT | 5.1 | Richard Puddephatt | Systems Integration Testing (SIT) | SITAG | Complete | COMPLETE |  |  |  |  |
| 1080 | 1.4.1.4.4.2.2 | Artefact review (via SITAG) and updates |  | 27d | 2024-04-09 A | 2024-05-15 A | 1079 | 100% |  |  | 2024-04-09 | 2024-05-15 | 27d | 2024-01-25 | 2024-03-13 |  |  |  |  | SI Test |  | SIT | 5.0 | Richard Puddephatt | Systems Integration Testing (SIT) | SITAG | Complete | COMPLETE |  |  |  |  |
| 1081 | 1.4.1.4.4.2.3 | SIT Non-Functional Testing Test Data Approach & Plan approved | milestone | 0d | 2024-05-15 A | 2024-05-15 A | 1077FF, 1080 | 100% |  |  | 2024-05-15 | 2024-05-15 | 0d | 2024-03-20 | 2024-03-20 |  |  |  |  | SI Test | PP,IPA | SIT | 5.24 | Richard Puddephatt | Systems Integration Testing (SIT) | SITAG | Complete | COMPLETE | T3-TE-0113 | T3 |  |  |
| 1082 | 1.4.1.4.4.3 | **Test scenarios & Test Cases** |  | 98d? | 2024-03-04 A | 2024-07-17 |  | 81% | 18.66d? |  | 2024-03-04 | 2024-07-17 | 123d | 2023-07-24 | 2024-01-17 |  |  |  | -0 | N/A | N/A | SIT | 5.21 | N/A | Systems Integration Testing (SIT) | SITAG |  |  |  |  |  |  |
| 1083 | 1.4.1.4.4.3.1 | **Theme 1** |  | 78d | 2024-03-04 A | 2024-06-19 A |  | 100% |  |  | 2024-03-04 | 2024-06-19 | 78d |  |  |  |  |  | -0 | N/A | N/A | SIT | 5.21 | N/A | Systems Integration Testing (SIT) | SITAG |  |  |  |  | -448.67 |  |
| 1084 | 1.4.1.4.4.3.1.1 | Develop Test Scenarios & Test Cases |  | 33d | 2024-03-04 A | 2024-04-17 A | 1073 | 100% |  |  | 2024-03-04 | 2024-04-17 | 33d |  |  |  |  |  |  | SI Test | SI Test, PP | SIT | 5.21 |  |  | SITAG | Complete | COMPLETE |  |  |  |  |
| 1085 | 1.4.1.4.4.3.1.2 | Industry Review Workshop |  | 1d | 2024-04-18 A | 2024-04-18 A | 1084 | 100% |  |  | 2024-04-18 | 2024-04-18 | 1d |  |  |  |  |  |  | SI Test, PP | SI Test, PP | SIT | 5.21 |  |  | SITAG | Complete | COMPLETE |  |  |  |  |
| 1086 | 1.4.1.4.4.3.1.3 | Industry Consultation Review |  | 7d | 2024-05-02 A | 2024-05-10 A | 1085FS+9d | 100% |  |  | 2024-05-02 | 2024-05-10 | 7d |  |  |  |  |  |  | SI Test, PP | SI Test, PP | SIT | 5.21 |  |  | SITAG | Complete | COMPLETE |  |  |  |  |
| 1087 | 1.4.1.4.4.3.1.4 | Review with NFT Working Group |  | 5d | 2024-05-31 A | 2024-06-06 A | 1086FS+14d | 100% |  |  | 2024-05-31 | 2024-06-06 | 5d |  |  |  |  |  |  | SI Test, PP | SI Test, PP | SIT | 5.21 |  |  | SITAG | Complete | COMPLETE |  |  |  |  |
| 1088 | 1.4.1.4.4.3.1.5 | SIT NFT Scenarios & Test Cases Approved - Theme 1 | milestone | 0d | 2024-06-19 A | 2024-06-19 A | 1087FS+9d | 100% |  |  | 2024-06-19 | 2024-06-19 | 0d |  |  |  |  |  |  | SI Test | SI Test, PP | SIT | 5.30 | Roger Robar | Systems Integration Testing (SIT) | SITAG | Complete | COMPLETE | T3-TE-0114 | T3 |  | 30/7/24: Approved at esitag on 26/7/24 |
| 1089 | 1.4.1.4.4.3.2 | **Theme 2** |  | 98d | 2024-03-04 A | 2024-07-17 A |  | 100% |  |  | 2024-03-04 | 2024-07-17 | 98d |  |  |  |  |  |  | N/A | N/A | SIT | 5.21 | N/A | Systems Integration Testing (SIT) | SITAG |  |  |  |  | -448.67 |  |
| 1090 | 1.4.1.4.4.3.2.1 | Develop Test Scenarios & Test Cases |  | 53d | 2024-03-04 A | 2024-05-15 A | 1073 | 100% |  |  | 2024-03-04 | 2024-05-15 | 53d |  |  |  |  |  |  | SI Test | SI Test, PP | SIT | 5.21 |  |  | SITAG | Complete | COMPLETE |  |  |  |  |
| 1091 | 1.4.1.4.4.3.2.2 | Industry Review Workshop |  | 1d | 2024-05-16 A | 2024-05-16 A | 1090 | 100% |  |  | 2024-05-16 | 2024-05-16 | 1d |  |  |  |  |  |  | SI Test, PP | SI Test, PP | SIT | 5.21 |  |  | SITAG | Complete | COMPLETE |  |  |  |  |
| 1092 | 1.4.1.4.4.3.2.3 | Industry Consultation Review |  | 7d | 2024-05-20 A | 2024-05-28 A | 1091FS+1d | 100% |  |  | 2024-05-20 | 2024-05-28 | 7d |  |  |  |  |  |  | SI Test, PP | SI Test, PP | SIT | 5.21 |  |  | SITAG | Complete | COMPLETE |  |  |  |  |
| 1093 | 1.4.1.4.4.3.2.4 | Review with NFT Working Group |  | 5d | 2024-06-28 A | 2024-07-04 A | 1092FS+22d | 100% |  |  | 2024-06-28 | 2024-07-04 | 5d |  |  |  |  |  |  | SI Test, PP | SI Test, PP | SIT | 5.21 |  |  | SITAG | Complete | COMPLETE |  |  |  |  |
| 1094 | 1.4.1.4.4.3.2.5 | SIT NFT Scenarios & Test Cases Approved - Theme 2 | milestone | 0d | 2024-07-17 A | 2024-07-17 A | 1093FS+9d | 100% |  |  | 2024-07-17 | 2024-07-17 | 0d |  |  |  |  |  |  | SI Test | SI Test, PP | SIT | 5.22 |  | Systems Integration Testing (SIT) | SITAG | Complete | COMPLETE | T3-TE-0115 | T3 |  |  |
| 1095 | 1.4.1.4.4.3.3 | **Theme 3** |  | 98d? | 2024-03-04 A | 2024-07-17 |  | 100% |  | 2024-09-18 | 2024-03-04 | 2024-07-17 | 123d |  |  |  |  |  | -0 | N/A | N/A | SIT | 6.0 | N/A | Systems Integration Testing (SIT) | SITAG |  |  |  |  | -448.67 |  |
| 1096 | 1.4.1.4.4.3.3.1 | Develop Test Scenarios & Test Cases |  | 63d | 2024-03-04 A | 2024-05-29 A | 1073 | 100% |  |  | 2024-03-04 | 2024-05-29 | 63d |  |  |  |  |  |  | SI Test | SI Test, PP | SIT | 6.0 |  |  | SITAG | Complete | COMPLETE |  |  |  |  |
| 1097 | 1.4.1.4.4.3.3.2 | Industry Review Workshop |  | 1d | 2024-05-30 A | 2024-05-30 A | 1096 | 100% |  |  | 2024-05-30 | 2024-05-30 | 1d |  |  |  |  |  |  | SI Test, PP | SI Test, PP | SIT | 6.0 |  |  | SITAG | Complete | COMPLETE |  |  |  |  |
| 1098 | 1.4.1.4.4.3.3.3 | Industry Consultation Review |  | 6d | 2024-06-10 A | 2024-06-17 A | 1097FS+6d | 100% |  |  | 2024-06-10 | 2024-06-17 | 6d |  |  |  |  |  |  | SI Test, PP | SI Test, PP | SIT | 6.0 |  |  | SITAG | Complete | COMPLETE |  |  |  |  |
| 1099 | 1.4.1.4.4.3.3.4 | Review with NFT Working Group |  | 5d | 2024-06-28 A | 2024-07-04 A | 1098FS+8d | 100% |  |  | 2024-06-28 | 2024-07-04 | 30d |  |  |  |  |  |  | SI Test, PP | SI Test, PP | SIT | 6.0 | Roger Robar |  | SITAG | Complete | COMPLETE |  |  |  |  |
| 1100 | 1.4.1.4.4.3.3.5 | SIT NFT Scenarios & Test Cases Approved - Theme 3 | milestone | 0d | 2024-09-18 A | 2024-09-18 A | 1099FS+9d | 100% |  |  | 2024-09-18 | 2024-09-18 | 0d |  |  |  |  | start no earlier than 2024-09-18 |  | SI Test | SI Test, PP | SIT | 5.30 | Roger Robar | Systems Integration Testing (SIT) | SITAG | Complete | COMPLETE | T3-TE-0116 | T3 |  | 31/7/24: baseline date change approved at esitag on 26/7/24 |
| 1101 | 1.4.1.4.4.3.4 | **SIT NFT Programme RTTM** |  | 56d? | 2024-09-18 A | 2024-12-04 |  | 78% | 12.39d? |  | 2024-09-18 | 2024-10-16 | 0d |  |  | 32369d |  |  |  |  |  | SIT | 6.11 | David O'Riordan |  | SITAG | Overdue Start |  |  |  | -197.67 |  |
| 1102 | 1.4.1.4.4.3.4.1 | Develop Manual SIT NFT RTTM |  | 30d | 2024-09-18 A | 2024-10-29 A | 1100 | 100% |  |  | 2024-09-18 | 2024-10-29 | 0d |  |  |  |  |  |  |  |  | SIT | 6.11 | David O'Riordan |  | SITAG | Complete | COMPLETE |  |  |  |  |
| 1103 | 1.4.1.4.4.3.4.2 | LDP peer review |  | 10d | 2024-10-30 A | 2024-11-12 A | 1102 | 100% |  |  | 2024-10-30 | 2024-11-12 | 0d |  |  |  |  |  |  |  |  | SIT | 6.11 | David O'Riordan |  | SITAG | Complete | COMPLETE |  |  |  |  |
| 1104 | 1.4.1.4.4.3.4.3 | Review with SRO |  | 5d | 2024-11-13 A | 2024-11-19 A | 1103 | 100% |  |  | 2024-11-13 | 2024-11-19 | 0d |  |  |  |  |  |  |  |  | SIT | 6.11 | David O'Riordan |  | SITAG | Complete | COMPLETE |  |  |  |  |
| 1105 | 1.4.1.4.4.3.4.4 | DIP Manager / Code Bodies / Full SRO to review |  | 5d | 2024-11-13 A | 2024-11-19 | 1103 | 50% | 2.5d |  | 2024-11-13 | 2024-11-19 | 0d |  |  | 32369d | 0d |  |  |  |  | SIT | 6.12 | David O'Riordan |  | SITAG | Green | RED |  |  |  |  |
| 1106 | 1.4.1.4.4.3.4.5 | Manual SIT NFT RTTM Complete | milestone | 0d | 2024-11-19 | 2024-11-19 | 1104, 1105 |  |  |  | 2024-11-19 | 2024-11-19 | 0d |  |  | 32369d | 0d |  |  |  |  | SIT | 6.11 | David O'Riordan |  | SITAG | Green | RED |  |  | -30.29 |  |
| 1107 | 1.4.1.4.4.3.4.6 | Develop Automated SIT NFT RTTM |  | 10d | 2024-11-20 | 2024-12-03 | 1106 |  |  |  | 2024-11-20 | 2024-12-03 | 0d |  |  | 32369d | 0d |  |  |  |  | SIT | 6.11 | David O'Riordan |  | SITAG | Green | GREEN |  |  | -29.67 |  |
| 1108 | 1.4.1.4.4.3.4.7 | Review with SRO |  | 1d? | 2024-12-04 | 2024-12-04 | 1107 |  |  |  | 2024-12-04 | 2024-12-04 | 0d |  |  | 32369d |  |  |  |  |  | SIT | 6.11 | David O'Riordan |  | SITAG | Green | GREEN |  |  | -15.67 |  |
| 1109 | 1.4.1.4.4.3.4.8 | Automated SIT NFT RTTM Complete | milestone | 0d | 2024-12-03 | 2024-12-03 | 1107 |  |  |  | 2024-12-03 | 2024-12-03 | 0d |  |  | 32370d |  |  |  |  |  | SIT | 6.11 | David O'Riordan |  | SITAG | Green | GREEN |  |  | -16.29 |  |

Notes:
- 1107: 18/12/24 - Programme and SRO still agreeing a definition of the automated RTTM, action can't be completed until this is done.
- 1108: 18/12/24 - Programme and SRO still agreeing a definition of the automated RTTM, action can't be completed until this is done.
- 1109: 18/12/24 - Programme and SRO still agreeing a definition of the automated RTTM, action can't be completed until this is done.

| ID | WBS | Task | Type | Duration | Start | Finish | Predecessors | Complete | Remaining | Baseline start | Baseline finish | Baseline duration | Total slack | Free slack | Constraint | Responsible | Text9 | Task Status | Update Version | Sched Status | MHHS Resource Name | Text29 | RAG |
| --- | --- | --- | --- | --- | --- | --- | --- | --- | --- | --- | --- | --- | --- | --- | --- | --- | --- | --- | --- | --- | --- | --- | --- |
| 1110 | 1.4.1.4.4.3.5 | **Production of NFT RTTM** |  | 19d? | 2024-03-04 | 2024-03-28 |  |  |  | 2024-08-26 | 2024-10-11 | 0d | 32548d |  |  | SI Test | SIT | -693.67 | 6.15 | Overdue Start | David O'Riordan | SITAG |  |
| 1111 | 1.4.1.4.4.3.5.1 | Test Script updates identified |  | 1d? | 2024-03-04 | 2024-03-04 |  |  |  | 2025-01-23 | 2025-01-23 | 0d | 32548d | 0d |  | SI Test | SIT | -290.67 | 6.15 | Overdue Start | David O'Riordan | SITAG | GREEN |
| 1112 | 1.4.1.4.4.3.5.2 | Test Scripts updates |  | 1d | 2024-03-05 | 2024-03-05 | 1111 |  |  | 2025-01-24 | 2025-01-24 | 0d | 32565d |  |  | SI Test | SIT | -289.67 | 6.15 | Overdue Start | David O'Riordan | SITAG | GREEN |
| 1113 | 1.4.1.4.4.3.5.3 | RTTM Updated Additional Static RTTM WBS items |  | 10d | 2024-03-04 | 2024-03-15 | 1111FS-1d |  |  | 2025-01-23 | 2025-02-05 | 0d | 32548d | 0d |  | SI Test | SIT | -290.67 | 6.15 | Overdue Start | David O'Riordan | SITAG | GREEN |
| 1114 | 1.4.1.4.4.3.5.4 | Removal of de-scoped TCs from the RTTMs |  | 5d | 2024-03-11 | 2024-03-15 | 1113FS-5d |  |  | 2025-01-30 | 2025-02-05 | 0d | 32557d |  |  | SI Test | SIT | -283.67 | 6.15 | Overdue Start | David O'Riordan | SITAG | GREEN |
| 1115 | 1.4.1.4.4.3.5.5 | Update and stabilisation of all TC ADO IDs |  | 14d | 2024-03-11 | 2024-03-28 | 1113FS-5d |  |  | 2025-01-30 | 2025-02-18 | 0d | 32548d |  |  | SI Test | SIT | -283.67 | 6.15 | Overdue Start | David O'Riordan | SITAG | GREEN |
| 1116 | 1.4.1.4.4.3.5.6 | Addition and integration of Role tags to reqs in the Role RTTMs |  | 5d | 2024-03-11 | 2024-03-15 | 1113FS-5d |  |  | 2025-01-30 | 2025-02-05 | 0d | 32557d |  |  | SI Test | SIT | -283.67 | 6.15 | Overdue Start | David O'Riordan | SITAG | GREEN |
| 1117 | 1.4.1.4.4.3.5.7 | Update of the RTTM All sheet (porting of the individual RTTMs) |  | 7d | 2024-03-14 | 2024-03-22 | 1113FS-2d |  |  | 2025-02-04 | 2025-02-12 | 0d | 32552d | 0d |  | SI Test | SIT | -280.67 | 6.15 | Overdue Start | David O'Riordan | SITAG | GREEN |
| 1118 | 1.4.1.4.4.3.5.8 | Define Additional ADO Tags |  | 1d | 2024-03-13 | 2024-03-13 | 1113FS-3d |  |  | 2025-02-03 | 2025-02-03 | 0d | 32559d |  |  | SI Test | SIT | -281.67 | 6.15 | Overdue Start | David O'Riordan | SITAG | GREEN |
| 1119 | 1.4.1.4.4.3.5.9 | Non-Functional RTTM ready for import into ADO | milestone | 0d | 2024-03-22 | 2024-03-22 | 1117 |  |  | 2025-02-12 | 2025-02-12 | 0d | 32552d |  |  | SI Test | SIT | -272.29 | 6.15 | Overdue Start | David O'Riordan | SITAG | GREEN |
| 1120 | 1.4.1.4.4.3.5.10 | Further Interative Deepdive on the requirements to testcase mapping |  | 9d | 2024-03-11 | 2024-03-21 | 1117FS-10d |  |  | 2025-01-30 | 2025-02-11 | 0d | 32553d | 0d |  | SI Test | SIT | -283.67 | 6.15 | Overdue Start | David O'Riordan | SITAG | GREEN |
| 1121 | 1.4.1.4.4.3.5.11 | Internal review |  | 5d | 2024-03-11 | 2024-03-15 | 1120FS-9d |  |  | 2025-01-30 | 2025-02-05 | 0d | 32555d | 0d |  | SI Test | SIT | -283.67 | 6.15 | Overdue Start | David O'Riordan | SITAG | GREEN |
| 1122 | 1.4.1.4.4.3.5.12 | Issue Static RTTM to Code Bodies |  | 1d? | 2024-03-19 | 2024-03-19 | 1121FS+1d |  |  | 2025-02-07 | 2025-02-07 | 0d | 32555d | 0d |  | SI Test | SIT | -275.67 | 6.15 | Overdue Start | David O'Riordan | SITAG | GREEN |
| 1123 | 1.4.1.4.4.3.5.13 | Code Body Acceptance of RTTM | milestone | 0d | 2024-03-19 | 2024-03-19 | 1122 |  |  | 2024-10-30 | 2025-02-10 | 0d | 32555d |  |  | Code Bodies | SIT | -275.29 | 6.15 | Overdue Start | David O'Riordan | SITAG | GREEN |
| 1124 | 1.4.1.4.4.3.6 | **NFT (Theme 1, 2 and 3) DITL** |  | 18d | 2025-02-03 | 2025-02-26 |  |  |  | 2024-10-08 | 2024-10-17 | 0d | 32309d |  |  | SI Test | SIT | 6.33 | 6.15 | No BL | Dom Mooney | SITAG |  |
| 1125 | 1.4.1.4.4.3.6.1 | DITL Development |  | 10d | 2025-02-03 | 2025-02-14 |  |  |  | 2025-02-03 | 2025-02-14 | 0d | 32309d | 0d | start no earlier than 2025-02-03 | SI Test | SIT | 45.33 | 6.15 | Green | Dom Mooney | SITAG | GREEN |
| 1126 | 1.4.1.4.4.3.6.2 | SRO Review |  | 5d | 2025-02-17 | 2025-02-21 | 1125 |  |  | 2025-02-17 | 2025-02-21 | 0d | 32309d | 0d |  | SI Test | SIT | 59.33 | 6.15 | Green | Dom Mooney | SITAG | GREEN |
| 1127 | 1.4.1.4.4.3.6.3 | Post-SRO Review Changes |  | 3d | 2025-02-24 | 2025-02-26 | 1126 |  |  | 2025-02-24 | 2025-02-26 | 0d | 32309d | 0d |  | SI Test | SIT | 66.33 | 6.15 | Green | Dom Mooney | SITAG | GREEN |
| 1128 | 1.4.1.4.4.3.6.4 | Programme walkthrough with Theme 1 PPs on DITL | milestone | 0d | 2025-02-26 | 2025-02-26 | 1127 |  |  | 2025-02-26 | 2025-02-26 | 0d | 32309d |  |  | SI Test | SIT | 68.71 | 6.15 | Green | Dom Mooney | SITAG | GREEN |
| 1129 | 1.4.1.4.4.3.7 | **NFT Performance Tool Theme 1 Setup** |  | 268d? | 2024-03-04 A | 2025-03-12 |  | 98% | 4.84d? | 2024-03-04 | 2025-01-10 | 0d | 32299d |  |  |  | SIT | -205.67 | 6.1 | Overdue Start | David O'Riordan | SITAG |  |
| 1130 | 1.4.1.4.4.3.7.1 | Theme 1 injection tool initial POC |  | 85d? | 2024-03-04 A | 2024-06-28 A |  | 100% |  | 2024-03-04 | 2024-06-28 | 0d |  |  |  |  | SIT |  | 6.1 | Complete | David O'Riordan | SITAG | COMPLETE |
| 1131 | 1.4.1.4.4.3.7.2 | Theme 1 injection tool configuration and validation against DIP SIM (IR7.1) |  | 38d | 2024-07-01 A | 2024-08-21 A | 1130 | 100% |  | 2024-07-01 | 2024-08-21 | 0d |  |  |  |  | SIT |  | 6.1 | Complete | David O'Riordan | SITAG | COMPLETE |
| 1132 | 1.4.1.4.4.3.7.3 | Theme 1 injection tool configuration and validation against DIP SIM (IR8.1) |  | 29d | 2024-08-22 A | 2024-10-01 A | 1131 | 100% |  | 2024-08-22 | 2024-10-01 | 0d |  |  |  |  | SIT |  | 6.1 | Complete | David O'Riordan | SITAG | COMPLETE |
| 1133 | 1.4.1.4.4.3.7.4 | Theme 1 injection tool configuration and validation againast UIT DIP (IR8.1) |  | 11d | 2024-10-02 A | 2024-10-16 A | 1132 | 100% |  | 2024-10-02 | 2024-10-16 | 0d |  |  |  |  | SIT |  | 6.1 | Complete | David O'Riordan | SITAG | COMPLETE |
| 1134 | 1.4.1.4.4.3.7.5 | Theme 1 injection tool configuration and validation against SIT-B DIP (IR8.3) |  | 3d? | 2025-03-10 | 2025-03-12 | 1545FS+10d |  |  | 2025-01-06 | 2025-01-08 | 0d | 32299d |  |  |  | SIT | 80.33 | 6.1 | Red | David O'Riordan | SITAG | RED |

Notes:
- 1110: 19/12/24 - Programme due to revisit and update these dates.
- 1111: 19/12/24 - Programme due to revisit and update these dates.
- 1112: 19/12/24 - Programme due to revisit and update these dates.
- 1113: 19/12/24 - Programme due to revisit and update these dates.
- 1114: 19/12/24 - Programme due to revisit and update these dates.
- 1115: 19/12/24 - Programme due to revisit and update these dates.
- 1116: 19/12/24 - Programme due to revisit and update these dates.
- 1117: 19/12/24 - Programme due to revisit and update these dates.
- 1118: 19/12/24 - Programme due to revisit and update these dates.
- 1119: 19/12/24 - Programme due to revisit and update these dates.
- 1120: 19/12/24 - Programme due to revisit and update these dates.
- 1121: 19/12/24 - Programme due to revisit and update these dates.
- 1122: 19/12/24 - Programme due to revisit and update these dates.
- 1123: 19/12/24 - Programme due to revisit and update these dates.

| ID | WBS | Task | Type | Duration | Start | Finish | Predecessors | Complete | Remaining | Baseline start | Baseline finish | Baseline duration | Baseline 1 start | Baseline 1 finish | Total slack | Free slack | Constraint | Baseline cost | Responsible | Involved | Text9 | Update Version | MHHS Resource Name | MHHS Programme Phase | Text29 | Action | Sched Status | RAG | Task Status | Milestone ID | Tier |
| --- | --- | --- | --- | --- | --- | --- | --- | --- | --- | --- | --- | --- | --- | --- | --- | --- | --- | --- | --- | --- | --- | --- | --- | --- | --- | --- | --- | --- | --- | --- | --- |
| 1135 | 1.4.1.4.4.4 | **Environments (SIT B)** |  | 134d | 2024-08-27 A | 2025-02-28 |  |  | 134d | 2024-08-27 | 2025-01-03 | 0d | 2024-07-30 | 2024-08-05 | 31603d |  |  | -0 | N/A | N/A | SIT | 5.0 | Heath Thomas | Systems Integration Testing (SIT) | SITAG |  |  |  |  |  |  |
| 1136 | 1.4.1.4.4.4.1 | **PP Environments (SIT B)** |  | 0d | 2024-08-27 A | 2024-08-27 A |  | 100% |  | 2024-08-27 | 2024-08-27 | 0d | 2024-07-30 | 2024-08-05 |  |  |  | -0 | N/A | N/A | SIT | 5.0 | Heath Thomas | Systems Integration Testing (SIT) | SITAG |  |  |  |  |  |  |
| 1137 | 1.4.1.4.4.4.1.1 | Deployment of MHHS solution code to SIT B environments | milestone | 0d | 2024-08-27 A | 2024-08-27 A |  | 100% |  | 2024-08-27 | 2024-08-27 | 0d | 2024-07-30 | 2024-08-05 |  |  | start no earlier than 2024-08-27 |  | PP | SI Test | SIT | 5.21 | Heath Thomas | Systems Integration Testing (SIT) | SITAG | 26/3/24: Lee said change to SB and align to IR7 | Complete | COMPLETE |  |  |  |
| 1138 | 1.4.1.4.4.4.2 | **SI Environments (SIT B)** |  | 0d | 2024-08-27 A | 2024-08-27 A |  | 100% |  | 2024-08-27 | 2024-08-27 | 0d | 2024-07-30 | 2024-08-05 |  |  |  | -0 | N/A | N/A | SIT | 5.0 | Heath Thomas | Systems Integration Testing (SIT) | SITAG |  |  |  |  |  |  |
| 1139 | 1.4.1.4.4.4.2.1 | Coordinate deployment of MHHS solution code to SIT Participants' SIT B environments | milestone | 0d | 2024-08-27 A | 2024-08-27 A | 1137SS | 100% |  | 2024-08-27 | 2024-08-27 | 0d | 2024-07-30 | 2024-08-05 |  |  |  |  | SI Test | PP | SIT | 5.21 | Heath Thomas | Systems Integration Testing (SIT) | SITAG |  | Complete | COMPLETE |  |  |  |
| 1140 | 1.4.1.4.4.4.3 | **Helix and Avanade Environments Upscale** |  | 5d | 2025-02-24 | 2025-02-28 |  |  |  | 2024-12-23 | 2025-01-03 | 0d |  |  | 31603d |  |  |  |  |  | SIT | 6.0 | Heath Thomas |  | SITAG |  | Overdue Start |  | -686.67 |  |  |
| 1141 | 1.4.1.4.4.4.3.1 | Environment Uplift Window |  | 5d | 2025-02-24 | 2025-02-28 | 1545 |  |  | 2024-12-23 | 2025-01-03 | 0d |  |  | 31603d | 0d |  |  |  |  | SIT | 6.0 |  |  | SITAG |  | Red | RED | 66.33 |  |  |
| 1142 | 1.4.1.4.4.5 | **Test Data - Non-Functional and Operational (SIT B)** |  | 25d? | 2025-02-24 | 2025-03-28 |  |  |  | 2025-01-06 | 2025-03-14 | 0d |  |  | 31603d |  |  |  |  |  | SIT | 6.0 |  |  | SITAG |  | Overdue Start |  | -686.67 |  |  |
| 1143 | 1.4.1.4.4.5.1 | **Data Load** |  | 25d? | 2025-02-24 | 2025-03-28 |  |  |  | 2025-01-06 | 2025-03-14 | 0d |  |  | 31603d |  |  |  |  |  | SIT | 6.0 | Richard Puddephatt |  | SITAG |  | Overdue Start |  | -689.67 |  |  |
| 1144 | 1.4.1.4.4.5.1.1 | Non-Functional Theme 1 (Avenade) Data Load |  | 5d? | 2025-02-24 | 2025-02-28 | 1545 |  |  | 2025-02-24 | 2025-02-28 | 0d |  |  | 31603d | 0d |  |  | SI Test |  | SIT | 6.15 | Richard Puddephatt |  | SITAG |  | Green | GREEN | 66.33 | T3-TE-0126 | T3 |
| 1145 | 1.4.1.4.4.5.1.2 | Non-Functional Theme 2 & 3 (Helix, Avenade & PPs) Data Load |  | 5d | 2025-03-24 | 2025-03-28 | 1604FS+1d |  |  | 2025-03-24 | 2025-03-28 | 0d |  |  | 31633d | 0d |  |  | SI Test |  | SIT | 6.15 | Richard Puddephatt |  | SITAG |  | Green | GREEN | 94.33 | T3-TE-0127 | T3 |
| 1146 | 1.4.1.4.4.5.1.3 | Non-Functional Themes 2 & 3 (LDSO's and DCC) Data Load |  | 15d | 2025-03-03 | 2025-03-21 | 1141 |  |  | 2025-03-03 | 2025-03-21 | 0d |  |  | 31638d | 5d |  |  | SI Test |  | SIT | 6.15 | Richard Puddephatt |  | SITAG |  | Green | GREEN | 73.33 | T3-TE-0128 | T3 |
| 1147 | 1.4.1.4.4.5.1.4 | Operational Themes 1, 2 & 3 (Batch 2) (LDSO's and DCC) Data Load |  | 20d? | 2025-03-03 | 2025-03-28 | 1141 |  |  | 2025-03-03 | 2025-03-28 | 0d |  |  | 31603d | 0d | start no earlier than 2025-01-06 |  | SI Test |  | SIT | 6.15 | Richard Puddephatt |  | SITAG |  | Green | GREEN | 73.33 | T3-TE-0129 | T3 |
| 1148 | 1.4.1.4.4.5.1.5 | Operational Themes 1, 2 & 3 (Batch 2) (Helix, Avenade & PPs) Data Load |  | 5d | 2025-03-24 | 2025-03-28 | 1604FS+1d |  |  | 2025-03-24 | 2025-03-28 | 0d |  |  | 31603d | 0d |  |  | SI Test |  | SIT | 6.15 | Richard Puddephatt |  | SITAG |  | Green | GREEN | 94.33 | T3-TE-0130 | T3 |
| 1149 | 1.4.1.4.4.5.1.6 | Non-Functional and Operational Test Data Preparation Complete | milestone | 0d | 2025-03-28 | 2025-03-28 | 1148 |  |  | 2025-03-28 | 2025-03-28 | 0d |  |  | 32287d |  |  |  | SI Test |  | SIT | 6.15 | Richard Puddephatt |  | SITAG |  | Green | GREEN | 98.71 | T3-TE-0131 | T3 |
| 1150 | 1.4.1.4.4.5.1.7 | Non-Functional Theme 2 & 3 PP Preparation | milestone | 0d | 2025-03-28 | 2025-03-28 | 1145 |  |  | 2025-03-31 | 2025-05-02 | 0d |  |  | 32287d |  |  |  | SI Test |  | SIT | 6.15 | Richard Puddephatt |  | SITAG |  | Green | GREEN | 98.71 |  |  |
| 1151 | 1.4.1.4.4.6 | **SIT Non-Functional Test Readiness Report** |  | 70d | 2024-12-23 | 2025-03-28 |  |  |  | 2024-06-25 | 2025-03-07 | 44d | 2024-06-25 | 2024-08-19 | 31610d |  |  | -0 | N/A | N/A | SIT | 5.0 | Roger Robar | Systems Integration Testing (SIT) | SITAG |  |  |  |  |  |  |
| 1152 | 1.4.1.4.4.6.1 | **SIT Non-Functional Theme 1 Overarching Test Readiness Report** |  | 50d | 2024-12-23 | 2025-02-28 |  |  |  | 2024-06-25 | 2025-01-10 | 40d | 2024-06-25 | 2024-08-19 | 31610d |  |  |  | N/A | N/A | SIT | 6.15 | Roger Robar | Systems Integration Testing (SIT) | SITAG |  |  |  |  |  |  |
| 1153 | 1.4.1.4.4.6.1.1 | Develop Overarching SIT Non-Functional Theme 1 Overarching Test Readiness Report |  | 14d | 2024-12-23 | 2025-01-09 | 397 |  |  | 2024-12-02 | 2024-12-20 | 20d | 2024-07-16 | 2024-08-12 | 31610d | 0d |  |  | SI Test |  | SIT | 6.15 | Roger Robar | Systems Integration Testing (SIT) | SITAG |  | Red | RED | 3.33 |  |  |
| 1154 | 1.4.1.4.4.6.1.2 | SRO review |  | 5d | 2025-01-10 | 2025-01-16 | 1153 |  |  | 2025-01-10 | 2025-01-16 |  |  |  | 31610d | 0d |  |  |  |  | SIT | 6.15 | Roger Robar |  | SITAG |  | Green | GREEN | 21.33 |  |  |
| 1155 | 1.4.1.4.4.6.1.3 | NFTWG paper day | milestone | 0d | 2025-01-16 | 2025-01-16 | 1154 |  |  | 2025-01-16 | 2025-01-16 |  |  |  | 32333d | 0d |  |  |  |  | SIT | 6.15 | Roger Robar |  | SITAG |  | Green | GREEN | 27.71 |  |  |
| 1156 | 1.4.1.4.4.6.1.4 | NFTWG review the Non-Functional Theme 1 Overarching Test Readiness Report | milestone | 0d | 2025-01-23 | 2025-01-23 | 1155FS+5d |  |  | 2025-01-23 | 2025-01-23 |  |  |  | 32333d |  |  |  |  |  | SIT | 6.15 | Roger Robar |  | SITAG |  | Green | GREEN | 34.71 |  |  |
| 1157 | 1.4.1.4.4.6.1.5 | Update Non-Functional Theme 1 Overarching Test Readiness Report following SRO / NFTWG feedback |  | 19d | 2025-01-17 | 2025-02-12 | 1154 |  |  | 2025-01-17 | 2025-02-12 |  |  |  | 31610d | 0d |  |  |  |  | SIT | 6.15 | Roger Robar |  | SITAG |  | Green | GREEN | 28.33 |  |  |
| 1158 | 1.4.1.4.4.6.1.6 | SITAG paper day | milestone | 0d | 2025-02-12 | 2025-02-12 | 1157 |  |  | 2025-02-12 | 2025-02-12 |  |  |  | 31610d | 0d |  |  |  |  | SIT | 6.15 | Roger Robar |  | SITAG |  | Green | GREEN | 54.71 |  |  |
| 1159 | 1.4.1.4.4.6.1.7 | SITAG endorse Non-Functional Theme 1 Overarching Test Readiness Report | milestone | 0d | 2025-02-19 | 2025-02-19 | 1158FS+5d |  |  | 2025-02-19 | 2025-02-19 |  |  |  | 31610d | 7d |  |  |  |  | SIT | 6.15 | Roger Robar |  | SITAG |  | Green | GREEN | 61.71 |  |  |
| 1160 | 1.4.1.4.4.6.1.8 | eSITAG approve Non-Functional Theme 1 Overarching Test Readiness Report | milestone | 0d | 2025-02-28 | 2025-02-28 | 1144, 1159 |  |  | 2025-02-28 | 2025-02-28 |  |  |  | 31603d | 0d |  |  |  |  | SIT | 6.15 | Roger Robar |  | SITAG |  | Green | GREEN | 70.71 |  |  |

Notes:
- 1144: 18/12/24 - SITAG approved the extension of Settlement testing and the postponement of NF / Ops data loads and testing, this date has been rebaselined to reflect this.
- 1145: 18/12/24 - SITAG approved the extension of Settlement testing and the postponement of NF / Ops data loads and testing, this date has been rebaselined to reflect this.
- 1146: 18/12/24 - SITAG approved the extension of Settlement testing and the postponement of NF / Ops data loads and testing, this date has been rebaselined to reflect this.
- 1147: 18/12/24 - SITAG approved the extension of Settlement testing and the postponement of NF / Ops data loads and testing, this date has been rebaselined to reflect this.
- 1148: 18/12/24 - SITAG approved the extension of Settlement testing and the postponement of NF / Ops data loads and testing, this date has been rebaselined to reflect this.
- 1149: 18/12/24 - SITAG approved the extension of Settlement testing and the postponement of NF / Ops data loads and testing, this date has been rebaselined to reflect this.
- 1150: 18/12/24 - SITAG approved the extension of Settlement testing and the postponement of NF / Ops data loads and testing, this activity has been removed to reflect this.

| ID | WBS | Task | Type | Duration | Start | Finish | Predecessors | Baseline start | Baseline finish | Baseline duration | Total slack | Free slack | Constraint | Text9 | Task Status | Update Version | Sched Status | MHHS Resource Name | RAG | Text29 |
| --- | --- | --- | --- | --- | --- | --- | --- | --- | --- | --- | --- | --- | --- | --- | --- | --- | --- | --- | --- | --- |
| 1161 | 1.4.1.4.4.6.2 | **SIT Non-Functional Overarching Test Readiness Report Theme 2 & 3** |  | 55d | 2025-01-13 | 2025-03-28 |  | 2025-01-13 | 2025-03-28 |  | 31688d |  |  | SIT | -779.67 | 6.15 | Overdue Start | Roger Robar | RED | SITAG |
| 1162 | 1.4.1.4.4.6.2.1 | Develop Overarching SIT Non-Functional Overarching Test Readiness Report Theme 2 & 3 |  | 17d | 2025-01-13 | 2025-02-04 |  | 2025-01-13 | 2025-02-04 |  | 32294d | 0d | start no earlier than 2025-01-13 | SIT | 24.33 | 6.15 | Green | Roger Robar | GREEN | SITAG |
| 1163 | 1.4.1.4.4.6.2.2 | SRO review |  | 5d | 2025-02-05 | 2025-02-11 | 1162 | 2025-02-05 | 2025-02-11 |  | 32294d | 0d |  | SIT | 47.33 | 6.15 | Green | Roger Robar | GREEN | SITAG |
| 1164 | 1.4.1.4.4.6.2.3 | NFTWG paper day | milestone | 0d | 2025-02-11 | 2025-02-11 | 1163 | 2025-02-11 | 2025-02-11 |  | 32294d | 0d |  | SIT | 53.71 | 6.15 | Green | Roger Robar | GREEN | SITAG |
| 1165 | 1.4.1.4.4.6.2.4 | NFTWG review the Non-Functional Overarching Test Readiness Report Theme 2 & 3 | milestone | 0d | 2025-02-18 | 2025-02-18 | 1164FS+5d | 2025-02-18 | 2025-02-18 |  | 32294d | 0d |  | SIT | 60.71 | 6.15 | Green | Roger Robar | GREEN | SITAG |
| 1166 | 1.4.1.4.4.6.2.5 | Update Non-Functional Overarching Test Readiness Report Theme 2 & 3 following SRO / NFTWG feedback |  | 16d | 2025-02-19 | 2025-03-12 | 1165 | 2025-02-19 | 2025-03-12 |  | 32294d | 0d |  | SIT | 61.33 | 6.15 | Green | Roger Robar | GREEN | SITAG |
| 1167 | 1.4.1.4.4.6.2.6 | SITAG paper day | milestone | 0d | 2025-03-12 | 2025-03-12 | 1166 | 2025-03-12 | 2025-03-12 |  | 32294d | 0d |  | SIT | 82.71 | 6.15 | Green | Roger Robar | GREEN | SITAG |
| 1168 | 1.4.1.4.4.6.2.7 | SITAG endorse Non-Functional Overarching Test Readiness Report Theme 2 & 3 | milestone | 0d | 2025-03-19 | 2025-03-19 | 1167FS+5d | 2025-03-19 | 2025-03-19 |  | 32294d |  |  | SIT | 89.71 | 6.15 | Green | Roger Robar | GREEN | SITAG |
| 1169 | 1.4.1.4.4.6.2.8 | eSITAG approve Non-Functional Overarching Test Readiness Report Theme 2 & 3 | milestone | 0d | 2025-03-28 | 2025-03-28 | 1145, 1146 | 2025-03-28 | 2025-03-28 |  | 31633d | 0d |  | SIT | 98.71 | 6.15 | Green | Roger Robar | GREEN | SITAG |
| 1170 | 1.4.1.4.4.6.3 | **SIT Non-Functional Execution Model** |  | 38d | 2024-12-23 | 2025-02-12 |  | 2025-01-20 | 2025-02-12 |  | 31728d |  |  | SIT | -778.67 | 6.15 | Overdue Start | David O'Riordan | RED | SITAG |
| 1171 | 1.4.1.4.4.6.3.1 | **Theme 1** |  | 18d | 2025-01-20 | 2025-02-12 |  | 2025-01-20 | 2025-02-12 |  | 32319d |  |  | SIT | -778.67 | 6.15 | Overdue Start | David O'Riordan | RED | SITAG |
| 1172 | 1.4.1.4.4.6.3.1.1 | Develop execution model Theme 1 |  | 3d | 2025-01-20 | 2025-01-22 |  | 2025-01-20 | 2025-01-22 | 0d | 32319d | 0d | start no earlier than 2025-01-20 | SIT | 31.33 | 6.15 | Green | David O'Riordan | GREEN | SITAG |
| 1173 | 1.4.1.4.4.6.3.1.2 | SRO provide feedback |  | 5d | 2025-01-23 | 2025-01-29 | 1172 | 2025-01-23 | 2025-01-29 | 0d | 32319d | 0d |  | SIT | 34.33 | 6.15 | Green | David O'Riordan | GREEN | SITAG |
| 1174 | 1.4.1.4.4.6.3.1.3 | Address SRO feedback on execution model |  | 2d | 2025-01-30 | 2025-01-31 | 1173 | 2025-01-30 | 2025-01-31 | 0d | 32319d | 0d |  | SIT | 41.33 | 6.15 | Green | David O'Riordan | GREEN | SITAG |
| 1175 | 1.4.1.4.4.6.3.1.4 | Finalise execution model |  | 3d | 2025-02-03 | 2025-02-05 | 1174 | 2025-02-03 | 2025-02-05 | 0d | 32319d | 0d |  | SIT | 45.33 | 6.15 | Green | David O'Riordan | GREEN | SITAG |
| 1176 | 1.4.1.4.4.6.3.1.5 | SITWG paper day | milestone | 0d | 2025-02-05 | 2025-02-05 | 1175 | 2025-02-05 | 2025-02-05 | 0d | 32319d | 0d |  | SIT | 47.71 | 6.15 | Green | David O'Riordan | GREEN | SITAG |
| 1177 | 1.4.1.4.4.6.3.1.6 | SITWG update on execution model | milestone | 0d | 2025-02-12 | 2025-02-12 | 1176FS+5d | 2025-02-12 | 2025-02-12 | 0d | 32319d |  |  | SIT | 54.71 | 6.15 | Green | David O'Riordan | GREEN | SITAG |
| 1178 | 1.4.1.4.4.6.3.2 | **Theme 2 & 3** |  | 18d | 2025-01-20 | 2025-02-12 |  | 2025-01-20 | 2025-02-12 | 0d | 32319d |  |  | SIT | -778.67 | 6.15 | Overdue Start | David O'Riordan | RED | SITAG |
| 1179 | 1.4.1.4.4.6.3.2.1 | Develop execution model Theme 2& 3 |  | 3d | 2025-01-20 | 2025-01-22 |  | 2025-01-20 | 2025-01-22 | 0d | 32319d | 0d | start no earlier than 2025-01-20 | SIT | 31.33 | 6.15 | Green | David O'Riordan | GREEN | SITAG |
| 1180 | 1.4.1.4.4.6.3.2.2 | SRO provide feedback |  | 5d | 2025-01-23 | 2025-01-29 | 1179 | 2025-01-23 | 2025-01-29 | 0d | 32319d | 0d |  | SIT | 34.33 | 6.15 | Green | David O'Riordan | GREEN | SITAG |
| 1181 | 1.4.1.4.4.6.3.2.3 | Address SRO feedback on execution model |  | 2d | 2025-01-30 | 2025-01-31 | 1180 | 2025-01-30 | 2025-01-31 | 0d | 32319d | 0d |  | SIT | 41.33 | 6.15 | Green | David O'Riordan | GREEN | SITAG |
| 1182 | 1.4.1.4.4.6.3.2.4 | Finalise execution model |  | 3d | 2025-02-03 | 2025-02-05 | 1181 | 2025-02-03 | 2025-02-05 | 0d | 32319d | 0d |  | SIT | 45.33 | 6.15 | Green | David O'Riordan | GREEN | SITAG |
| 1183 | 1.4.1.4.4.6.3.2.5 | SITWG paper day | milestone | 0d | 2025-02-05 | 2025-02-05 | 1182 | 2025-02-05 | 2025-02-05 | 0d | 32319d | 0d |  | SIT | 47.71 | 6.15 | Green | David O'Riordan | GREEN | SITAG |
| 1184 | 1.4.1.4.4.6.3.2.6 | SITWG update on execution model | milestone | 0d | 2025-02-12 | 2025-02-12 | 1183FS+5d | 2025-02-12 | 2025-02-12 |  | 32319d |  |  | SIT | 54.71 | 6.15 | Green | David O'Riordan | GREEN | SITAG |

| ID | WBS | Task | Type | Duration | Start | Finish | Predecessors | Complete | Remaining | Baseline start | Baseline finish | Baseline duration | Baseline 1 start | Baseline 1 finish | Total slack | Free slack | Constraint | Baseline cost | Text9 | Task Status | Update Version | Sched Status | MHHS Resource Name | RAG | Text29 | Responsible | Involved | MHHS Programme Phase | Tier | Milestone ID | Artefact ID | Guidance |
| --- | --- | --- | --- | --- | --- | --- | --- | --- | --- | --- | --- | --- | --- | --- | --- | --- | --- | --- | --- | --- | --- | --- | --- | --- | --- | --- | --- | --- | --- | --- | --- | --- |
| 1185 | 1.4.1.4.4.6.3.3 | **SIT Non-Functional Progress reporting** |  | 25d | 2024-12-23 | 2025-01-24 |  |  |  | 2024-12-30 | 2025-01-24 |  |  |  | 31728d |  |  |  | SIT | -778.67 | 6.14 | Overdue Start | David O'Riordan | RED | SITAG |  |  |  |  |  |  |  |
| 1186 | 1.4.1.4.4.6.3.3.1 | Determine reporting methodology |  | 2d | 2025-01-23 | 2025-01-24 | 1179, 1172 |  |  | 2025-01-23 | 2025-01-24 |  |  |  | 32332d |  |  |  | SIT | 34.33 | 6.14 | Green | David O'Riordan | GREEN | SITAG |  |  |  |  |  |  |  |
| 1187 | 1.4.1.4.4.6.3.3.2 | Implement reporting |  | 15d | 2024-12-23 | 2025-01-10 | 842, 397, 1088, 1094, 1100 |  |  | 2024-12-30 | 2025-01-10 | 0d | 2024-08-26 | 2024-08-26 | 31728d | 56d |  |  | SIT | 3.33 | 6.14 | Green | David O'Riordan | GREEN | SITAG | SI Test | PP,IPA | Systems Integration Testing (SIT) | T2 |  |  |  |
| 1188 | 1.4.1.4.4.7 | SIT Non-Functional Testing Preparation Complete Theme 1 | milestone | 0d | 2025-02-28 | 2025-02-28 | 1144 |  |  | 2025-02-28 | 2025-02-28 |  |  |  | 32307d |  | start no earlier than 2025-02-28 |  | SIT | 70.71 | 6.15 | Green | David O'Riordan | GREEN | SITAG |  |  |  |  | T2-TE-0700 |  |  |
| 1189 | 1.4.1.4.4.8 | SIT Non-Functional Testing Preparation Complete Theme 2 & 3 | milestone | 0d | 2025-03-28 | 2025-03-28 | 1145, 1146, 398FS+5d |  |  | 2025-03-28 | 2025-03-28 |  |  |  | 32287d |  |  |  | SIT | 98.71 | 6.15 | Green | David O'Riordan | GREEN | SITAG | SI Test |  |  | T2 | T2-TE-1100 |  |  |
| 1190 | 1.4.1.4.5 | **SIT Operational Preparation** |  | 646d? | 2022-10-31 A | 2025-04-21 |  | 69% | 199.43d? | 2024-02-01 | 2025-01-31 | 283d | 2023-08-03 | 2025-03-10 | 32271d |  |  | -0 | SIT |  | 5.0 |  | N/A |  | SITAG | N/A | N/A | Systems Integration Testing (SIT) |  |  |  |  |
| 1191 | 1.4.1.4.5.1 | **Test Approach & Plan** |  | 75d | 2024-02-01 A | 2024-05-15 A |  | 100% |  | 2024-02-01 | 2024-05-15 | 75d | 2024-02-01 | 2024-05-15 |  |  |  | -0 | SIT |  | 5.0 |  | N/A |  | SITAG | N/A | N/A | Systems Integration Testing (SIT) |  |  |  |  |
| 1192 | 1.4.1.4.5.1.1 | Develop document with SITWG |  | 25d | 2024-02-01 A | 2024-03-06 A |  | 100% |  | 2024-02-01 | 2024-03-06 | 25d | 2024-02-01 | 2024-03-06 |  |  | must start on 2024-02-01 |  | SIT |  | 5.0 | Complete |  | COMPLETE | SITAG | SI Test |  | Systems Integration Testing (SIT) |  |  |  |  |
| 1193 | 1.4.1.4.5.1.2 | Draft document review with Code Bodies |  | 4d | 2024-03-21 A | 2024-03-26 A | 1192FS+10d | 100% |  | 2024-03-21 | 2024-03-26 | 10d | 2024-03-07 | 2024-03-20 |  |  |  |  | SIT |  | 5.0 | Complete |  | COMPLETE | SITAG | SI Test | Code Bodies | Systems Integration Testing (SIT) |  |  |  |  |
| 1194 | 1.4.1.4.5.1.3 | Industry Consultation |  | 10d | 2024-03-27 A | 2024-04-09 A | 1193 | 100% |  | 2024-03-27 | 2024-04-09 | 10d |  |  |  |  |  |  | SIT |  | 5.1 | Complete |  | COMPLETE | SITAG | PP |  | Systems Integration Testing (SIT) |  |  |  |  |
| 1195 | 1.4.1.4.5.1.4 | Artefact review (via SITAG) and updates |  | 26d | 2024-04-10 A | 2024-05-15 A | 1194 | 100% |  | 2024-04-10 | 2024-05-15 | 30d | 2024-03-21 | 2024-05-15 |  |  |  |  | SIT |  | 5.0 | Complete |  | COMPLETE | SITAG | SI Test | PP,IPA,Code Bodies | Systems Integration Testing (SIT) |  |  |  |  |
| 1196 | 1.4.1.4.5.1.5 | SIT Operational Testing Test Approach & Plan approved | milestone | 0d | 2024-05-15 A | 2024-05-15 A | 1195 | 100% |  | 2024-05-15 | 2024-05-15 | 0d | 2024-05-15 | 2024-05-15 |  |  |  |  | SIT |  | 5.24 | Complete |  | COMPLETE | SITAG | SI Test | PP | Systems Integration Testing (SIT) | T3 | T3-TE-0029 | MHHS-ART073 |  |
| 1197 | 1.4.1.4.5.2 | **Test Data Approach & Plan** |  | 36d | 2024-03-27 A | 2024-05-15 A |  | 100% |  | 2024-03-27 | 2024-05-15 | 36d | 2024-03-21 | 2024-05-15 |  |  |  | -0 | SIT |  | 5.0 |  | N/A |  | SITAG | N/A | N/A | Systems Integration Testing (SIT) |  |  |  |  |
| 1198 | 1.4.1.4.5.2.1 | Industry Consultation |  | 10d | 2024-03-27 A | 2024-04-09 A | 1194SS | 100% |  | 2024-03-27 | 2024-04-09 | 10d |  |  |  |  |  |  | SIT |  | 5.1 | Complete | Richard Puddephatt | COMPLETE | SITAG | PP |  | Systems Integration Testing (SIT) |  |  |  |  |
| 1199 | 1.4.1.4.5.2.2 | Artefact review (via SITAG) and updates |  | 26d | 2024-04-10 A | 2024-05-15 A | 1198 | 100% |  | 2024-04-10 | 2024-05-15 | 26d | 2024-03-21 | 2024-05-15 |  |  |  |  | SIT |  | 5.0 | Complete | Richard Puddephatt | COMPLETE | SITAG | SI Test |  | Systems Integration Testing (SIT) |  |  |  |  |
| 1200 | 1.4.1.4.5.2.3 | SIT Operational Testing Test Data Approach & Plan approved | milestone | 0d | 2024-05-15 A | 2024-05-15 A | 1199 | 100% |  | 2024-05-15 | 2024-05-15 | 0d | 2024-05-15 | 2024-05-15 |  |  |  |  | SIT |  | 5.0 | Complete | Richard Puddephatt | COMPLETE | SITAG | SI Test | PP,IPA | Systems Integration Testing (SIT) |  |  |  |  |
| 1201 | 1.4.1.4.5.3 | **Test scenarios & Test Cases** |  | 108d | 2024-04-10 A | 2024-09-06 A |  | 100% |  | 2024-04-10 | 2025-01-31 | 116d | 2023-07-24 | 2024-01-17 |  |  |  | -0 | SIT |  | 5.21 |  | Richard Puddephatt |  | SITAG | N/A | N/A | Systems Integration Testing (SIT) |  |  |  |  |
| 1202 | 1.4.1.4.5.3.1 | **Theme 1** |  | 108d | 2024-04-10 A | 2024-09-06 A |  | 100% |  | 2024-04-10 | 2024-09-06 | 96d |  |  |  |  |  | -0 | SIT | -448.67 | 6.0 |  | Richard Puddephatt |  | SITAG | N/A | N/A | Systems Integration Testing (SIT) |  |  |  |  |
| 1203 | 1.4.1.4.5.3.1.1 | Develop Test Scenarios & Test Cases |  | 53d | 2024-04-10 A | 2024-06-21 A | 1194 | 100% |  | 2024-04-10 | 2024-06-21 | 16d |  |  |  |  |  |  | SIT |  | 6.0 | Complete | Richard Puddephatt | COMPLETE | SITAG | SI Test | SI Test, PP |  |  |  |  |  |
| 1204 | 1.4.1.4.5.3.1.2 | Industry Review Workshop |  | 1d | 2024-06-24 A | 2024-06-24 A | 1203 | 100% |  | 2024-06-24 | 2024-06-24 | 1d |  |  |  |  |  |  | SIT |  | 6.0 | Complete | Richard Puddephatt | COMPLETE | SITAG | SI Test, PP | SI Test, PP |  |  |  |  |  |
| 1205 | 1.4.1.4.5.3.1.3 | Industry Consultation Review |  | 6d | 2024-07-02 A | 2024-07-09 A | 1204FS+17d | 100% |  | 2024-07-02 | 2024-07-09 | 6d |  |  |  |  |  |  | SIT |  | 6.0 | Complete | Richard Puddephatt | COMPLETE | SITAG | SI Test, PP | SI Test, PP |  |  |  |  |  |
| 1206 | 1.4.1.4.5.3.1.4 | Review with SIT Working Group |  | 5d | 2024-08-19 A | 2024-08-23 A | 1205FS+16d | 100% |  | 2024-08-19 | 2024-08-23 | 5d |  |  |  |  |  |  | SIT |  | 6.0 | Complete | Richard Puddephatt | COMPLETE | SITAG | SI Test, PP | SI Test, PP |  |  |  |  |  |
| 1207 | 1.4.1.4.5.3.1.5 | SIT Operational Scenarios & Test Cases Approved - Theme 1 | milestone | 0d | 2024-09-06 A | 2024-09-06 A | 1206FS+10d | 100% |  | 2024-09-06 | 2024-09-06 | 0d |  |  |  |  | start no earlier than 2024-09-06 |  | SIT |  | 6.0 | Complete | Richard Puddephatt | COMPLETE | SITAG | SI Test | SI Test, PP | Systems Integration Testing (SIT) | T3 | T3-TE-0117 |  | 31/7/24: baseline date change approved at esitag on 26/7/24 |
| 1208 | 1.4.1.4.5.3.2 | **Theme 2** |  | 107d | 2024-04-10 A | 2024-09-06 A |  | 100% |  | 2024-04-10 | 2024-09-06 | 71d |  |  |  |  |  |  | SIT | -448.67 | 6.0 |  | Richard Puddephatt |  | SITAG | N/A | N/A | Systems Integration Testing (SIT) |  |  |  |  |
| 1209 | 1.4.1.4.5.3.2.1 | Develop Test Scenarios & Test Cases |  | 53d | 2024-04-10 A | 2024-06-21 A | 1194 | 100% |  | 2024-04-10 | 2024-06-21 | 31d |  |  |  |  | finish no earlier than 2024-06-21 |  | SIT |  | 6.0 | Complete | Richard Puddephatt | COMPLETE | SITAG | SI Test | SI Test, PP |  |  |  |  |  |
| 1210 | 1.4.1.4.5.3.2.2 | Industry Review Workshop |  | 1d | 2024-06-24 A | 2024-06-24 A | 1209 | 100% |  | 2024-06-24 | 2024-06-24 | 1d |  |  |  |  |  |  | SIT |  | 6.0 | Complete | Richard Puddephatt | COMPLETE | SITAG | SI Test, PP | SI Test, PP |  |  |  |  |  |
| 1211 | 1.4.1.4.5.3.2.3 | Industry Consultation Review |  | 6d | 2024-07-02 A | 2024-07-09 A | 1210FS+7d | 100% |  | 2024-07-02 | 2024-07-09 | 6d |  |  |  |  |  |  | SIT |  | 6.0 | Complete | Richard Puddephatt | COMPLETE | SITAG | SI Test, PP | SI Test, PP |  |  |  |  |  |
| 1212 | 1.4.1.4.5.3.2.4 | Review with SIT Working Group |  | 5d | 2024-08-19 A | 2024-08-23 A | 1211FS+11d | 100% |  | 2024-08-19 | 2024-08-23 | 5d |  |  |  |  |  |  | SIT |  | 6.0 | Complete | Richard Puddephatt | COMPLETE | SITAG | SI Test, PP | SI Test, PP |  |  |  |  |  |
| 1213 | 1.4.1.4.5.3.2.5 | SIT Operational Scenarios & Test Cases Approved - Theme 2 | milestone | 0d | 2024-09-06 A | 2024-09-06 A | 1212FS+10d | 100% |  | 2024-09-06 | 2024-09-06 | 0d |  |  |  |  |  |  | SIT |  | 6.0 | Complete | Richard Puddephatt | COMPLETE | SITAG | SI Test | SI Test, PP | Systems Integration Testing (SIT) | T3 | T3-TE-0118 |  |  |

| ID | WBS | Task | Type | Duration | Start | Finish | Predecessors | Complete | Remaining | Baseline start | Baseline finish | Total slack | Free slack | Constraint | Text9 | Task Status | Update Version | Sched Status | MHHS Resource Name | RAG | Responsible | Milestone ID | Text29 | Tier |
| --- | --- | --- | --- | --- | --- | --- | --- | --- | --- | --- | --- | --- | --- | --- | --- | --- | --- | --- | --- | --- | --- | --- | --- | --- |
| 1214 | 1.4.1.4.5.4 | **SIT Operations Manual** |  | 589d? | 2022-10-31 A | 2025-01-31 |  | 72% | 165.6d? | 2022-10-31 | 2025-01-31 | 32328d |  |  | SIT | -755.67 | 6.13 | Overdue Start | Helix |  |  |  |  |  |
| 1215 | 1.4.1.4.5.4.1 | **Version 1 SIT Operations Manual** |  | 35d | 2024-10-07 A | 2024-11-22 A |  | 100% |  | 2024-10-07 | 2024-11-22 |  |  |  | SIT | -755.67 | 6.13 | Overdue Start | Helix |  |  |  |  |  |
| 1216 | 1.4.1.4.5.4.1.1 | Creation of SIT Operations Manual Template |  | 8d | 2024-10-07 A | 2024-10-16 A |  | 100% |  | 2024-10-07 | 2024-10-16 |  |  | start no earlier than 2024-10-07 | SIT |  | 6.13 | Complete | Helix | COMPLETE |  |  |  |  |
| 1217 | 1.4.1.4.5.4.1.2 | November TORWG Paper Day | milestone | 0d | 2024-11-07 A | 2024-11-07 A | 1216FS+16d | 100% |  | 2024-11-07 | 2024-11-07 |  |  |  | SIT |  | 6.13 | Complete | Helix | COMPLETE |  |  |  |  |
| 1218 | 1.4.1.4.5.4.1.3 | November TORWG (Timeline and Next Steps for SIT Operations Manual) | milestone | 0d | 2024-11-14 A | 2024-11-14 A | 1217FS+5d | 100% |  | 2024-11-14 | 2024-11-14 |  |  |  | SIT |  | 6.13 | Complete | Helix | COMPLETE |  |  |  |  |
| 1219 | 1.4.1.4.5.4.1.4 | SIT Operations Manual Version 1 Shared with MHHSP | milestone | 0d | 2024-11-11 A | 2024-11-11 A | 1216FS+18d | 100% |  | 2024-11-11 | 2024-11-11 |  |  |  | SIT |  | 6.13 | Complete | Helix | COMPLETE |  |  |  |  |
| 1220 | 1.4.1.4.5.4.1.5 | MHHSP provide feedback on SIT Operations Manual Version 1 |  | 9d | 2024-11-12 A | 2024-11-22 A | 1219 | 100% |  | 2024-11-12 | 2024-11-22 |  |  |  | SIT |  | 6.13 | Complete | Helix | COMPLETE |  |  |  |  |
| 1221 | 1.4.1.4.5.4.1.6 | SIT Operations Manual Version 1 Shared with Programme Participants | milestone | 0d | 2024-11-13 A | 2024-11-13 A | 1216FS+20d | 100% |  | 2024-11-13 | 2024-11-13 |  |  |  | SIT |  | 6.13 | Complete | Helix | COMPLETE |  |  |  |  |
| 1222 | 1.4.1.4.5.4.1.7 | PPs provide feedback on SIT Operations Manual Version 1 |  | 7d | 2024-11-14 A | 2024-11-22 A | 1221 | 100% |  | 2024-11-14 | 2024-11-22 |  |  |  | SIT |  | 6.13 | Complete | Helix | COMPLETE |  |  |  |  |
| 1223 | 1.4.1.4.5.4.1.8 | Programme Participants and MHHSP Feedback and Actions Received (SIT Ops Manual Version 1) | milestone | 0d | 2024-11-22 A | 2024-11-22 A | 1222, 1220 | 100% |  | 2024-11-22 | 2024-11-22 |  |  |  | SIT |  | 6.13 | Complete | Helix | COMPLETE |  |  |  |  |
| 1224 | 1.4.1.4.5.4.2 | **Version 2 SIT Operations Manual** |  | 27d | 2024-11-12 A | 2024-12-18 A |  | 100% |  | 2024-11-12 | 2024-12-18 |  |  |  | SIT | -755.67 | 6.13 | Overdue Start | Helix |  |  |  |  |  |
| 1225 | 1.4.1.4.5.4.2.1 | Version 2 SIT Operations Manual (Composition) |  | 12d | 2024-11-12 A | 2024-11-27 A | 1217FS+2d | 100% |  | 2024-11-12 | 2024-11-27 |  |  |  | SIT |  | 6.13 | Complete | Helix | COMPLETE |  |  |  |  |
| 1226 | 1.4.1.4.5.4.2.2 | Version 2 SIT Operations Manual Completed | milestone | 0d | 2024-11-27 A | 2024-11-27 A | 1225 | 100% |  | 2024-11-27 | 2024-11-27 |  |  |  | SIT |  | 6.13 | Complete | Helix | COMPLETE | Helix | T3-TE-0132 | MCAG | T3 |
| 1227 | 1.4.1.4.5.4.2.3 | Version 2 SIT Operations Manual Shared with MHHSP & PPs for TORWG (Consultation Starts) | milestone | 0d | 2024-11-27 A | 2024-11-27 A | 1226 | 100% |  | 2024-11-27 | 2024-11-27 |  |  |  | SIT |  | 6.13 | Complete | Helix | COMPLETE |  |  |  |  |
| 1228 | 1.4.1.4.5.4.2.4 | Version 2 SIT Ops Manual - PP Consultation (Iterative Feedback Process) |  | 10d | 2024-11-28 A | 2024-12-11 A | 1227 | 100% |  | 2024-11-28 | 2024-12-11 |  |  |  | SIT |  | 6.13 | Complete | Helix | COMPLETE |  |  |  |  |
| 1229 | 1.4.1.4.5.4.2.5 | Version 2 SIT Ops Manual - PP Consultation Completed | milestone | 0d | 2024-12-11 A | 2024-12-11 A | 1228 | 100% |  | 2024-12-11 | 2024-12-11 |  |  |  | SIT |  | 6.13 | Complete | Helix | COMPLETE |  |  |  |  |
| 1230 | 1.4.1.4.5.4.2.6 | December TORWG Paper Day | milestone | 0d | 2024-12-04 A | 2024-12-04 A | 1225FS+5d | 100% |  | 2024-12-04 | 2024-12-04 |  |  |  | SIT |  | 6.13 | Complete | Helix | COMPLETE |  |  |  |  |
| 1231 | 1.4.1.4.5.4.2.7 | December TORWG (Initial Feedback, Common Themes and Comments) | milestone | 0d | 2024-12-11 A | 2024-12-11 A | 1230FS+5d | 100% |  | 2024-12-11 | 2024-12-11 |  |  |  | SIT |  | 6.13 | Complete | Helix | COMPLETE |  |  |  |  |
| 1232 | 1.4.1.4.5.4.2.8 | December Extraordinary TORWG Paper Day | milestone | 0d | 2024-12-11 A | 2024-12-11 A | 1229 | 100% |  | 2024-12-11 | 2024-12-11 |  |  |  | SIT |  | 6.13 | Complete | Helix | COMPLETE |  |  |  |  |
| 1233 | 1.4.1.4.5.4.2.9 | Publication of key themes from consultation to eTORWG |  | 2d | 2024-12-12 A | 2024-12-13 A | 1232 | 100% |  | 2024-12-12 | 2024-12-13 |  |  |  | SIT |  | 6.14 | Complete |  | COMPLETE |  |  |  |  |
| 1234 | 1.4.1.4.5.4.2.10 | December Extraordinary TORWG (Summary of Version 2 Feedback and Response Approach Shared with PPs) | milestone | 0d | 2024-12-18 A | 2024-12-18 A | 1233FS+3d | 100% |  | 2024-12-18 | 2024-12-18 |  |  |  | SIT |  | 6.13 | Complete | Helix | COMPLETE |  |  |  |  |
| 1235 | 1.4.1.4.5.4.3 | **Version 3 (Final) SIT Operations Manual** |  | 44d | 2024-11-28 A | 2025-01-28 |  | 70% | 13.4d | 2024-11-28 | 2025-01-28 | 32330d |  |  | SIT | -755.67 | 6.13 | Overdue Start | Helix |  |  |  |  |  |
| 1236 | 1.4.1.4.5.4.3.1 | Update SIT Operations Manual (Final) Version 3 (with Comments Received From Version 2) [Pre-Christmas Furlough] |  | 17d | 2024-11-28 A | 2024-12-20 | 1226, 181FF | 90% | 1.7d | 2024-11-28 | 2024-12-20 | 32330d | 0d |  | SIT |  | 6.13 | Green | Helix | GREEN |  |  |  |  |
| 1237 | 1.4.1.4.5.4.3.2 | Update SIT Operations Manual (Final) Version 3 (with Comments Received From Version 2) [Post-Christmas Furlough] |  | 5d | 2025-01-02 | 2025-01-08 | 1236FS+8d |  |  | 2025-01-02 | 2025-01-08 | 32330d | 0d |  | SIT | 13.33 | 6.13 | Green | Helix | GREEN |  |  |  |  |
| 1238 | 1.4.1.4.5.4.3.3 | SIT Operations Manual (Final) Version 3 Completed | milestone | 0d | 2025-01-08 | 2025-01-08 | 1237 |  |  | 2025-01-08 | 2025-01-08 | 32330d | 0d |  | SIT | 19.71 | 6.13 | Green | Helix | GREEN |  | T3-TE-0133 | MCAG | T3 |
| 1239 | 1.4.1.4.5.4.3.4 | January TORWG Paper Day | milestone | 0d | 2025-01-08 | 2025-01-08 | 1238 |  |  | 2025-01-08 | 2025-01-08 | 32330d | 0d |  | SIT | 19.71 | 6.13 | Green | Helix | GREEN |  |  |  |  |
| 1240 | 1.4.1.4.5.4.3.5 | January TORWG (SIT Operations Manual Agreement) [Assurance Meeting] | milestone | 0d | 2025-01-15 | 2025-01-15 | 1239FS+5d |  |  | 2025-01-15 | 2025-01-15 | 32330d | 0d |  | SIT | 26.71 | 6.13 | Green | Helix | GREEN |  |  |  |  |
| 1241 | 1.4.1.4.5.4.3.6 | January MCAG Paper Day (Final SIT Operations Manual Submitted) | milestone | 0d | 2025-01-21 | 2025-01-21 | 1240FS+4d |  |  | 2025-01-21 | 2025-01-21 | 32330d | 0d |  | SIT | 32.71 | 6.13 | Green | Helix | GREEN |  |  |  |  |
| 1242 | 1.4.1.4.5.4.3.7 | January MCAG (Final SIT Operations Manual Endorsement) [Advisory Group Sign-off] | milestone | 0d | 2025-01-28 | 2025-01-28 | 1241FS+5d |  |  | 2025-01-28 | 2025-01-28 | 32330d |  |  | SIT | 39.71 | 6.13 | Green | Helix | GREEN |  | T3-TE-0135 | MCAG | T3 |

Notes:
- 1226: 27/11/24 - New milestone added by Programme, awaiting formal SITAG approval.

| ID | WBS | Task | Type | Duration | Start | Finish | Predecessors | Complete | Remaining | Actual start | Actual finish | Baseline start | Baseline finish | Baseline duration | Total slack | Free slack | Constraint | Responsible | Text9 | Task Status | Update Version | Sched Status | MHHS Resource Name | RAG |
| --- | --- | --- | --- | --- | --- | --- | --- | --- | --- | --- | --- | --- | --- | --- | --- | --- | --- | --- | --- | --- | --- | --- | --- | --- |
| 1243 | 1.4.1.4.5.4.4 | **Elexon / Helix Service Management Test Prep** |  | 119d? | 2024-08-01 A | 2025-01-14 |  | 87% | 15.65d? |  |  | 2024-07-15 | 2025-01-31 | 0d | 31701d |  |  | Helix | SIT | -688.67 | 6.13 | Overdue Start | Helix |  |
| 1244 | 1.4.1.4.5.4.4.1 | **Incident Management Build** |  | 75d? | 2024-08-05 A | 2024-11-15 A |  | 100% |  |  |  | 2024-08-05 | 2024-11-15 | 0d |  |  |  | Helix | SIT | -728.67 | 6.13 | Overdue Start | Helix |  |
| 1245 | 1.4.1.4.5.4.4.1.1 | Build |  | 40d | 2024-08-05 A | 2024-09-27 A |  | 100% |  |  |  | 2024-09-27 | 2024-09-27 | 0d |  |  | finish no earlier than 2024-09-27 | Helix | SIT |  | 6.13 | Complete | Helix | COMPLETE |
| 1246 | 1.4.1.4.5.4.4.1.2 | Test |  | 15d | 2024-09-30 A | 2024-10-18 A | 1245 | 100% |  |  |  | 2024-10-18 | 2024-10-18 | 0d |  |  | finish no earlier than 2024-10-18 | Helix | SIT |  | 6.13 | Complete | Helix | COMPLETE |
| 1247 | 1.4.1.4.5.4.4.1.3 | Deploy |  | 20d | 2024-10-21 A | 2024-11-15 A | 1246 | 100% |  |  |  | 2024-11-15 | 2024-11-15 | 0d |  |  | finish no earlier than 2024-11-15 | Helix | SIT |  | 6.13 | Complete | Helix | COMPLETE |
| 1248 | 1.4.1.4.5.4.4.1.4 | Incident Management Build & Configuration Complete | milestone | 0d | 2024-11-15 A | 2024-11-15 A | 1247 | 100% |  |  |  |  |  |  |  |  |  | Helix | SIT |  | 6.13 | Complete | Helix | COMPLETE |
| 1249 | 1.4.1.4.5.4.4.2 | **Major Incident Management Build & Configuration** |  | 0d? | 2024-11-15 | 2024-11-15 |  | 100% |  | 2024-10-02 | 2025-01-14 | 2024-10-02 | 2025-01-14 | 0d |  |  |  | Helix | SIT | -728.67 | 6.13 | Overdue Start | Helix |  |
| 1250 | 1.4.1.4.5.4.4.2.1 | Build |  | 40d | 2024-10-02 A | 2024-11-26 A |  | 100% |  |  |  | 2024-11-26 | 2024-11-26 | 0d |  |  | finish no earlier than 2024-11-26 | Helix | SIT |  | 6.13 | Complete | Helix | COMPLETE |
| 1251 | 1.4.1.4.5.4.4.2.2 | Test |  | 15d | 2024-11-27 A | 2024-12-17 A | 1250 | 100% |  |  |  | 2024-12-17 | 2024-12-17 | 0d |  |  | finish no earlier than 2024-12-17 | Helix | SIT |  | 6.13 | Complete | Helix | COMPLETE |
| 1252 | 1.4.1.4.5.4.4.2.3 | Deploy |  | 20d | 2024-12-18 A | 2025-01-14 A | 1251 | 100% |  |  |  | 2025-01-14 | 2025-01-14 | 0d |  |  | finish no earlier than 2025-01-14 | Helix | SIT |  | 6.13 | Complete | Helix | COMPLETE |
| 1253 | 1.4.1.4.5.4.4.2.4 | Major Incident Management Build & Configuration Complete | milestone | 0d | 2025-01-14 A | 2025-01-14 A | 1252 | 100% |  |  |  |  |  |  |  |  |  | Helix | SIT |  | 6.13 | Complete | Helix | COMPLETE |
| 1254 | 1.4.1.4.5.4.4.3 | **Knowledge Management Build & Configuration** |  | 75d? | 2024-10-02 A | 2025-01-14 A |  | 100% |  |  |  | 2024-10-02 | 2025-01-14 | 0d |  |  |  | Helix | SIT | -728.67 | 6.13 | Overdue Start | Helix |  |
| 1255 | 1.4.1.4.5.4.4.3.1 | Build |  | 40d | 2024-10-02 A | 2024-11-26 A |  | 100% |  |  |  | 2024-11-26 | 2024-11-26 | 0d |  |  | finish no earlier than 2024-11-26 | Helix | SIT |  | 6.13 | Complete | Helix | COMPLETE |
| 1256 | 1.4.1.4.5.4.4.3.2 | Test |  | 15d | 2024-11-27 A | 2024-12-17 A | 1255 | 100% |  |  |  | 2024-12-17 | 2024-12-17 | 0d |  |  | finish no earlier than 2024-12-17 | Helix | SIT |  | 6.13 | Complete | Helix | COMPLETE |
| 1257 | 1.4.1.4.5.4.4.3.3 | Deploy |  | 20d | 2024-12-18 A | 2025-01-14 A | 1256 | 100% |  |  |  | 2025-01-14 | 2025-01-14 | 0d |  |  | finish no earlier than 2025-01-14 | Helix | SIT |  | 6.13 | Complete | Helix | COMPLETE |
| 1258 | 1.4.1.4.5.4.4.3.4 | Knowledge Management Build & Configuration Complete | milestone | 0d | 2025-01-14 A | 2025-01-14 A | 1257 | 100% |  |  |  |  |  |  |  |  |  | Helix | SIT |  | 6.13 | Complete | Helix | COMPLETE |
| 1259 | 1.4.1.4.5.4.4.4 | **Problem Management Build & Configuration** |  | 1d? | 2024-08-01 | 2024-08-01 |  | 73% | 0.27d? | 2024-10-02 |  | 2024-10-02 | 2025-01-14 | 0d |  |  |  | Helix | SIT | -728.67 | 6.13 | Overdue Start | Helix |  |
| 1260 | 1.4.1.4.5.4.4.4.1 | Build |  | 40d | 2024-10-02 A | 2024-11-26 A |  | 100% |  |  |  | 2024-11-26 | 2024-11-26 | 0d |  |  | finish no earlier than 2024-11-26 | Helix | SIT |  | 6.13 | Complete | Helix | COMPLETE |
| 1261 | 1.4.1.4.5.4.4.4.2 | Test |  | 15d | 2024-11-27 A | 2024-12-17 A | 1260 | 100% |  |  |  | 2024-12-17 | 2024-12-17 | 0d |  |  | finish no earlier than 2024-12-17 | Helix | SIT |  | 6.13 | Complete | Helix | COMPLETE |
| 1262 | 1.4.1.4.5.4.4.4.3 | Deploy |  | 20d | 2024-12-18 | 2025-01-14 | 1261 |  |  |  |  | 2025-01-14 | 2025-01-14 | 0d | 31701d | 0d | finish no earlier than 2025-01-14 | Helix | SIT | -1.67 | 6.13 | Green | Helix | GREEN |
| 1263 | 1.4.1.4.5.4.4.4.4 | Problem Management Build & Configuration Complete | milestone | 0d | 2025-01-14 | 2025-01-14 | 1262 |  |  |  |  |  |  |  | 31701d | 0d | start no earlier than 2025-01-14 | Helix | SIT | 25.71 | 6.13 | No BL | Helix | GREEN |
| 1264 | 1.4.1.4.5.4.4.5 | **Change Management Build & Configuration** |  | 75d? | 2024-10-02 A | 2025-01-14 |  | 73% | 20d? |  |  | 2024-10-02 | 2025-01-14 | 0d |  |  |  | Helix | SIT | -728.67 | 6.13 | Overdue Start | Helix |  |
| 1265 | 1.4.1.4.5.4.4.5.1 | Build |  | 40d | 2024-10-02 A | 2024-11-26 A |  | 100% |  |  |  | 2024-11-26 | 2024-11-26 | 0d |  |  | finish no earlier than 2024-11-26 | Helix | SIT |  | 6.13 | Complete | Helix | COMPLETE |
| 1266 | 1.4.1.4.5.4.4.5.2 | Test |  | 15d | 2024-11-27 A | 2024-12-17 A | 1265 | 100% |  |  |  | 2024-12-17 | 2024-12-17 | 0d |  |  | finish no earlier than 2024-12-17 | Helix | SIT |  | 6.13 | Complete | Helix | COMPLETE |
| 1267 | 1.4.1.4.5.4.4.5.3 | Deploy |  | 20d | 2024-12-18 | 2025-01-14 | 1266 |  |  |  |  | 2025-01-14 | 2025-01-14 | 0d | 31701d | 0d | finish no earlier than 2025-01-14 | Helix | SIT | -1.67 | 6.13 | Green | Helix | GREEN |
| 1268 | 1.4.1.4.5.4.4.5.4 | Change Management Build & Configuration Complete | milestone | 0d | 2025-01-14 | 2025-01-14 | 1267 |  |  |  |  |  |  |  | 31701d | 0d | start no earlier than 2025-01-14 | Helix | SIT | 25.71 | 6.13 | No BL | Helix | GREEN |

| ID | WBS | Task | Type | Duration | Start | Finish | Predecessors | Complete | Remaining | Baseline start | Baseline finish | Baseline duration | Total slack | Free slack | Constraint | Responsible | Text9 | Task Status | Update Version | Sched Status | MHHS Resource Name | RAG | Milestone ID | Text29 | Tier |
| --- | --- | --- | --- | --- | --- | --- | --- | --- | --- | --- | --- | --- | --- | --- | --- | --- | --- | --- | --- | --- | --- | --- | --- | --- | --- |
| 1269 | 1.4.1.4.5.4.4.6 | **Service Catalogue Management Build & Configuration** |  | 75d? | 2024-10-02 A | 2025-01-14 |  | 73% | 20d? | 2024-10-02 | 2025-01-14 | 0d |  |  |  | Helix | SIT | -728.67 | 6.13 | Overdue Start | Helix |  |  |  |  |
| 1270 | 1.4.1.4.5.4.4.6.1 | Build |  | 40d | 2024-10-02 A | 2024-11-26 A |  | 100% |  | 2024-11-26 | 2024-11-26 | 0d |  |  | finish no earlier than 2024-11-26 | Helix | SIT |  | 6.13 | Complete | Helix | COMPLETE |  |  |  |
| 1271 | 1.4.1.4.5.4.4.6.2 | Test |  | 15d | 2024-11-27 A | 2024-12-17 A | 1270 | 100% |  | 2024-12-17 | 2024-12-17 | 0d |  |  | finish no earlier than 2024-12-17 | Helix | SIT |  | 6.13 | Complete | Helix | COMPLETE |  |  |  |
| 1272 | 1.4.1.4.5.4.4.6.3 | Deploy |  | 20d | 2024-12-18 | 2025-01-14 | 1271 |  |  | 2025-01-14 | 2025-01-14 | 0d | 31701d | 0d | finish no earlier than 2025-01-14 | Helix | SIT | -1.67 | 6.13 | Green | Helix | GREEN |  |  |  |
| 1273 | 1.4.1.4.5.4.4.6.4 | Service Catalogue Management Build & Configuration Complete | milestone | 0d | 2025-01-14 | 2025-01-14 | 1272 |  |  |  |  |  | 31701d | 0d | start no earlier than 2025-01-14 | Helix | SIT | 25.71 | 6.13 | No BL | Helix | GREEN |  |  |  |
| 1274 | 1.4.1.4.5.4.4.7 | ServiceNow SIT Ops Available | milestone | 0d? | 2025-01-14 | 2025-01-14 | 1248, 1253, 1258, 1263, 1268, 1273 |  |  | 2025-01-14 | 2025-01-14 | 0d | 31701d | 13d | start no earlier than 2024-09-09 | Helix | SIT | 25.71 | 6.13 | Green | Helix | GREEN | T3-TE-0136 | SITAG | T3 |
| 1275 | 1.4.1.4.5.4.4.8 | **Helix Service Management Documentation (Service Design Pack)** |  | 102d | 2024-08-01 A | 2024-12-20 |  | 88% | 12.63d | 2024-09-09 | 2025-01-31 | 0d | 31718d | 30d |  | Helix | SIT | -49.67 | 6.0 | Overdue Start | Helix |  |  |  |  |
| 1276 | 1.4.1.4.5.4.4.8.1 | Document Drafting |  | 95d | 2024-08-01 A | 2024-12-11 |  | 95% | 4.75d | 2024-08-01 | 2024-12-11 | 0d | 31722d | 0d | finish no earlier than 2024-12-11 | Helix | SIT |  | 6.11 | Green | Helix | GREEN |  |  |  |
| 1277 | 1.4.1.4.5.4.4.8.2 | Internal Elexon Review |  | 3d | 2024-12-12 | 2024-12-16 | 1276 |  |  | 2024-12-12 | 2024-12-16 | 0d | 31722d |  | finish no earlier than 2024-12-16 | Helix | SIT | -7.67 | 6.11 | Green | Helix | GREEN |  |  |  |
| 1278 | 1.4.1.4.5.4.4.8.3 | Elexon Service Panel Review |  | 5d | 2024-12-16 | 2024-12-20 |  |  |  | 2024-12-16 | 2024-12-20 | 0d | 31718d | 0d | finish no earlier than 2024-12-20 | Helix | SIT | -3.67 | 6.11 | Green | Helix | GREEN |  |  |  |
| 1279 | 1.4.1.4.5.4.4.8.4 | Elexon Service Panel Sign off | milestone | 0d | 2024-12-20 | 2024-12-20 | 1278 |  |  | 2024-12-20 | 2024-12-20 | 0d | 31718d |  | start no earlier than 2024-12-20 | Helix | SIT | 0.71 | 6.11 | Green | Helix | GREEN |  |  |  |
| 1280 | 1.4.1.4.5.4.5 | **Incident Management Support** |  | 1d? | 2022-10-31 | 2022-10-31 |  |  |  |  |  |  |  |  |  | Helix | SIT | -755.67 | 6.13 | Overdue Start | Helix | 25d |  |  |  |
| 1281 | 1.4.1.4.5.4.5.1 | Identify Relevant Stakeholders to Support Incident Management Process |  | 10d | 2024-12-02 | 2024-12-13 |  |  |  | 2024-11-18 | 2024-11-29 | 0d | 32337d | 0d | start no earlier than 2024-12-02 | Helix | SIT | -17.67 | 6.13 | Red | Helix | RED |  |  |  |
| 1282 | 1.4.1.4.5.4.5.2 | Schedule Time to Upskill Stakeholders |  | 5d | 2024-12-16 | 2024-12-20 | 1281 |  |  | 2024-12-02 | 2024-12-06 | 0d | 32337d | 0d |  | Helix | SIT | -3.67 | 6.13 | Red | Helix | RED |  |  |  |
| 1283 | 1.4.1.4.5.4.5.3 | Helix Stakeholders Attendance at MHHS Defect Triage Meetings [Meeting Dates to be Confirmed] |  | 10d | 2025-01-06 | 2025-01-17 | 1282FS+10d |  |  | 2024-12-09 | 2024-12-20 | 0d | 32337d | 0d |  | Helix | SIT | 17.33 | 6.13 | Red | Helix | RED |  |  |  |
| 1284 | 1.4.1.4.5.4.6 | SIT Service Readiness (Elexon & Helix) Completed | milestone | 0d | 2025-01-17 | 2025-01-17 | 1283 |  |  | 2024-12-20 | 2024-12-20 | 0d | 32337d |  |  | Helix | SIT | 28.71 | 6.13 | Red | Helix | RED |  |  |  |
| 1285 | 1.4.1.4.5.4.7 | **SIT Service Readiness (External Parties)** |  | 71d | 2024-09-30 A | 2025-01-06 |  | 13% | 61.46d | 2024-09-30 | 2025-01-06 | 0d | 32346d |  |  | Helix | SIT | -755.67 | 6.13 | Overdue Start | Helix | RED |  |  |  |
| 1286 | 1.4.1.4.5.4.7.1 | Helix Engagement & Comms |  | 71d | 2024-09-30 A | 2025-01-06 |  | 23% | 55d | 2024-09-30 | 2025-01-06 | 0d | 32346d | 0d | start no earlier than 2024-09-30 | Helix | SIT |  | 6.13 | Green | Helix | GREEN |  |  |  |
| 1287 | 1.4.1.4.5.4.7.2 | Engagement Execution |  | 66d | 2024-10-07 A | 2025-01-06 |  | 17% | 55d | 2024-10-07 | 2025-01-06 | 0d | 32346d | 0d | start no earlier than 2024-10-07 | Helix | SIT |  | 6.13 | Green | Helix | GREEN |  |  |  |
| 1288 | 1.4.1.4.5.4.7.3 | Information Gathering |  | 32d | 2024-10-31 | 2024-12-13 |  |  |  | 2024-10-31 | 2024-11-27 | 0d | 32362d | 16d | start no earlier than 2024-10-31 | Helix | SIT | -49.67 | 6.13 | Red | Helix | RED |  |  |  |
| 1289 | 1.4.1.4.5.4.7.4 | SIT Participants Preparation |  | 32d | 2024-11-22 | 2025-01-06 |  |  |  | 2024-11-22 | 2025-01-06 | 0d | 32338d | 0d | start no earlier than 2024-11-22 | Helix | SIT | -27.67 | 6.13 | Green | Helix | GREEN |  |  |  |
| 1290 | 1.4.1.4.5.4.7.5 | SIT Service Readiness (External Parties) Completed | milestone | 0d | 2025-01-06 | 2025-01-06 | 1286, 1287, 1288, 1289 |  |  | 2025-01-06 | 2025-01-06 | 0d | 32346d |  |  | Helix | SIT | 17.71 | 6.13 | Green | Helix | GREEN |  |  |  |
| 1291 | 1.4.1.4.5.4.8 | **ServiceNow Support Portal Onboarding (Helix Suppliers & SIT Participants)** |  | 78d? | 2024-10-02 A | 2025-01-17 |  | 53% | 36.95d? | 2024-10-02 | 2025-01-17 | 0d |  |  |  | Helix | SIT | -755.67 | 6.13 | Overdue Start | Helix | RED |  |  |  |
| 1292 | 1.4.1.4.5.4.8.1 | **ServiceNow Portal Preparation and Planning** |  | 40d? | 2024-10-02 A | 2024-11-26 A |  | 100% |  | 2024-10-02 | 2024-11-26 | 0d |  |  |  | Helix | SIT | -755.67 | 6.13 | Overdue Start | Helix |  |  |  |  |
| 1293 | 1.4.1.4.5.4.8.1.1 | Define Supplier Requirements |  | 30d? | 2024-10-02 A | 2024-11-12 A |  | 100% |  | 2024-10-02 | 2024-11-12 | 0d |  |  | start no earlier than 2024-10-02 | Helix | SIT |  | 6.13 | Complete | Helix | COMPLETE |  |  |  |
| 1294 | 1.4.1.4.5.4.8.1.2 | Determine Supplier ServiceNow modules |  | 10d? | 2024-11-13 A | 2024-11-26 A | 1293 | 100% |  | 2024-11-13 | 2024-11-26 | 0d |  |  | finish no earlier than 2024-11-26 | Helix | SIT |  | 6.13 | Complete | Helix | COMPLETE |  |  |  |
| 1295 | 1.4.1.4.5.4.8.1.3 | Review compliance requirements, including data privacy and access limitations. |  | 10d? | 2024-11-13 A | 2024-11-26 A | 1293 | 100% |  | 2024-11-13 | 2024-11-26 | 0d |  |  | finish no earlier than 2024-11-26 | Helix | SIT |  | 6.13 | Complete | Helix | COMPLETE |  |  |  |
| 1296 | 1.4.1.4.5.4.8.1.4 | Conduct a security assessment to ensure the supplier complies with organisational policies. |  | 10d? | 2024-11-13 A | 2024-11-26 A | 1293 | 100% |  | 2024-11-13 | 2024-11-26 | 0d |  |  | finish no earlier than 2024-11-26 | Helix | SIT |  | 6.13 | Complete | Helix | COMPLETE |  |  |  |

| ID | WBS | Task | Type | Duration | Start | Finish | Predecessors | Complete | Remaining | Baseline start | Baseline finish | Baseline duration | Total slack | Free slack | Constraint | Baseline cost | Responsible | Text9 | Task Status | Update Version | Sched Status | MHHS Resource Name | RAG | Milestone ID | Text29 | Tier | Involved | MHHS Programme Phase |
| --- | --- | --- | --- | --- | --- | --- | --- | --- | --- | --- | --- | --- | --- | --- | --- | --- | --- | --- | --- | --- | --- | --- | --- | --- | --- | --- | --- | --- |
| 1297 | 1.4.1.4.5.4.8.2 | **ServiceNow Portal System Configuration** |  | 30d? | 2024-11-27 | 2025-01-07 |  |  |  | 2024-11-27 | 2025-01-07 | 0d |  |  |  |  | Helix | SIT | -755.67 | 6.13 | Overdue Start | Helix |  |  |  |  |  |  |
| 1298 | 1.4.1.4.5.4.8.2.1 | Create Supplier User Accounts |  | 14d | 2024-11-27 | 2024-12-16 | 1296, 1289SS |  |  | 2024-11-27 | 2024-12-10 | 0d | 32335d | 0d | finish no earlier than 2024-12-10 |  | Helix | SIT | -22.67 | 6.13 | yellow | Helix | RED |  |  |  |  |  |
| 1299 | 1.4.1.4.5.4.8.2.2 | Assign appropriate access based on the supplier’s needs and security requirements (e.g., read-only access, submit requests, etc.). |  | 10d? | 2024-12-17 | 2024-12-30 | 1298 |  |  | 2024-12-11 | 2024-12-24 | 0d | 32335d | 0d | finish no earlier than 2024-12-24 |  | Helix | SIT | -2.67 | 6.13 | yellow | Helix | RED |  |  |  |  |  |
| 1300 | 1.4.1.4.5.4.8.2.3 | Configure Access Controls |  | 10d? | 2024-12-31 | 2025-01-13 | 1299 |  |  | 2024-12-25 | 2025-01-07 | 0d | 32335d | 4d | finish no earlier than 2025-01-07 |  | Helix | SIT | 11.33 | 6.13 | yellow | Helix | RED |  |  |  |  |  |
| 1301 | 1.4.1.4.5.4.8.3 | **ServiceNow Portal Training and Documentation** |  | 5d? | 2025-01-06 | 2025-01-10 |  |  |  | 2025-01-06 | 2025-01-10 | 0d |  |  |  |  | Helix | SIT | -755.67 | 6.13 | Overdue Start | Helix |  |  |  |  |  |  |
| 1302 | 1.4.1.4.5.4.8.3.1 | Provide Training to the Supplier |  | 5d | 2025-01-06 | 2025-01-10 |  |  |  | 2025-01-06 | 2025-01-10 | 0d | 32331d | 0d | finish no earlier than 2025-01-10 |  | Helix | SIT | 17.33 | 6.13 | Green | Helix | GREEN |  |  |  |  |  |
| 1303 | 1.4.1.4.5.4.8.3.2 | Create Supplier Training Documentation |  | 5d | 2025-01-06 | 2025-01-10 |  |  |  | 2025-01-06 | 2025-01-10 | 0d | 32336d | 5d | finish no earlier than 2025-01-10 |  | Helix | SIT | 17.33 | 6.13 | Green | Helix | GREEN |  |  |  |  |  |
| 1304 | 1.4.1.4.5.4.8.4 | **ServiceNow Portal Testing and Validation** |  | 8d? | 2025-01-08 | 2025-01-17 |  |  |  | 2025-01-08 | 2025-01-17 | 0d |  |  |  |  | Helix | SIT | -755.67 | 6.13 | Overdue Start | Helix |  |  |  |  |  |  |
| 1305 | 1.4.1.4.5.4.8.4.1 | Conduct User Acceptance Testing (UAT) |  | 5d | 2025-01-13 | 2025-01-17 | 1302 |  |  | 2025-01-13 | 2025-01-17 | 0d | 32337d |  | finish no earlier than 2025-01-17 |  | Helix | SIT | 24.33 | 6.13 | Green | Helix | GREEN |  |  |  |  |  |
| 1306 | 1.4.1.4.5.4.8.4.2 | Validate Access and Security Controls |  | 5d | 2025-01-13 | 2025-01-17 | 1302 |  |  | 2025-01-13 | 2025-01-17 | 0d | 32331d | 0d | finish no earlier than 2025-01-14 |  | Helix | SIT | 24.33 | 6.13 | Green | Helix | GREEN |  |  |  |  |  |
| 1307 | 1.4.1.4.5.4.8.5 | ServiceNow Support Portal Onboarding (Helix Suppliers& SIT Participants) Completed | milestone | 0d | 2025-01-17 | 2025-01-17 | 1296, 1300, 1303, 1306 |  |  | 2025-01-17 | 2025-01-17 | 0d | 32331d | 3d | start no earlier than 2025-01-17 |  | Helix | SIT | 28.71 | 6.13 | Green | Helix | GREEN |  |  |  |  |  |
| 1308 | 1.4.1.4.5.4.9 | Stage 1 - Helix SIT Operational Readiness Completed | milestone | 0d | 2025-01-31 | 2025-01-31 |  |  |  | 2025-01-31 | 2025-01-31 | 0d | 32328d |  | start no earlier than 2025-01-31 |  | Helix | SIT | 42.33 | 6.13 | Green | Helix | GREEN | T3-TE-0137 | SITAG | T3 |  |  |
| 1309 | 1.4.1.4.5.4.10 | **Theme 3 (Batch 2)** |  | 65d | 2024-09-19 A | 2024-12-18 |  | 99% | 0.77d | 2024-09-19 | 2024-12-11 | 116d | 31675d |  |  | -0 | N/A | SIT | -448.67 | 6.0 |  | Steve Evans |  |  | SITAG |  | N/A | Systems Integration Testing (SIT) |
| 1310 | 1.4.1.4.5.4.10.1 | Conclude BCDR Scope with SRO, Code Bodies and DIP Manager |  | 22d | 2024-09-19 A | 2024-10-18 A |  | 100% |  | 2024-09-19 | 2024-10-18 | 0d |  |  | start no earlier than 2024-09-19 |  |  | SIT |  | 6.0 | Complete | Steve Evans | COMPLETE |  | SITAG |  |  |  |
| 1311 | 1.4.1.4.5.4.10.2 | Develop BDCR Test Scenarios & Test Cases (Batch 2) |  | 10d | 2024-10-14 A | 2024-10-25 A | 1310 | 100% |  | 2024-10-14 | 2024-10-25 | 0d |  |  |  |  |  | SIT |  | 6.0 | Complete | Steve Evans | COMPLETE |  | SITAG |  |  |  |
| 1312 | 1.4.1.4.5.4.10.3 | Develop DIP Test Scenarios and Test Cases (Batch 2) |  | 27d | 2024-09-19 A | 2024-10-25 A |  | 100% |  | 2024-09-19 | 2024-10-25 | 0d |  |  | start no earlier than 2024-09-19 |  |  | SIT |  | 6.0 | Complete | Steve Evans | COMPLETE |  | SITAG |  |  |  |
| 1313 | 1.4.1.4.5.4.10.4 | SRO Review |  | 5d | 2024-10-28 A | 2024-11-01 A | 1312 | 100% |  | 2024-10-28 | 2024-11-01 | 0d |  |  | start no earlier than 2024-10-28 |  |  | SIT |  | 6.0 | Complete | Steve Evans | COMPLETE |  | SITAG |  |  |  |
| 1314 | 1.4.1.4.5.4.10.5 | Industry Consultation (Batch 2) |  | 10d | 2024-11-11 A | 2024-11-22 A | 1313 | 100% |  | 2024-11-11 | 2024-11-22 | 1d |  |  |  |  | SI Test, PP | SIT |  | 6.0 | Complete | Steve Evans | COMPLETE |  | SITAG |  | SI Test, PP |  |
| 1315 | 1.4.1.4.5.4.10.6 | Review Feedback and Update |  | 4d | 2024-11-25 A | 2024-11-28 A | 1314 | 100% |  | 2024-11-25 | 2024-11-29 | 0d |  |  |  |  | SI Test | SIT |  | 6.13 | Complete | Steve Evans | COMPLETE |  | SITAG |  |  |  |
| 1316 | 1.4.1.4.5.4.10.7 | SITWG paper day | milestone | 0d | 2024-11-28 A | 2024-11-28 A | 1315 | 100% |  | 2024-11-28 | 2024-11-28 | 0d |  |  |  |  |  | SIT |  | 6.13 | Complete | Steve Evans | COMPLETE |  | SITAG |  |  |  |
| 1317 | 1.4.1.4.5.4.10.8 | Review with SIT WG (Batch 2) |  | 5d | 2024-11-29 A | 2024-12-05 A | 1316 | 100% |  | 2024-11-29 | 2024-12-05 | 0d |  |  |  |  | SI Test | SIT |  | 6.13 | Complete | Steve Evans | COMPLETE |  | SITAG |  |  |  |
| 1318 | 1.4.1.4.5.4.10.9 | SITWG endorse Theme 3 (Batch 2) | milestone | 0d | 2024-12-05 A | 2024-12-05 A | 1317 | 100% |  | 2024-12-05 | 2024-12-05 | 0d |  |  |  |  |  | SIT |  | 6.13 | Complete | Steve Evans | COMPLETE |  | SITAG |  |  |  |
| 1319 | 1.4.1.4.5.4.10.10 | SITAG paper day | milestone | 0d | 2024-12-11 | 2024-12-11 | 1318FS+4d |  |  | 2024-12-11 | 2024-12-11 | 0d | 31670d | 0d |  |  |  | SIT | -8.29 | 6.13 | Green | Steve Evans | GREEN |  | SITAG |  |  |  |
| 1320 | 1.4.1.4.5.4.10.11 | SITAG approve Theme 3 (Batch 2) |  | 1d | 2024-12-18 | 2024-12-18 | 1319FS+4d |  |  | 2024-12-18 | 2024-12-18 | 0d | 31670d | 92d |  |  | SI Test | SIT | -1.67 | 6.13 | Green | Steve Evans | GREEN | T3-TE-0138 | SITAG | T3 |  |  |

Notes:
- 1308: 27/11/24 - New milestone added by Programme, awaiting formal SITAG approval.
- 1311: 12/09/24 - Added new milestone for Batch 2
- 1313: 06/11/24 - SRO Review and Industry Workshop have both been moved to alleviate concurrent review with Batch 1.
- 1314: 12/09/24 - Forecast date changed in line with SI Plan.
- 1318: 09/12/24 - Endorsed with caveat that two test cases should be descoped, but this does not impact successor activity and still meant Batch was endorsed.

| ID | WBS | Task | Type | Duration | Start | Finish | Predecessors | Complete | Remaining | Baseline start | Baseline finish | Baseline duration | Total slack | Free slack | Constraint | Responsible | Text9 | Task Status | Update Version | Sched Status | MHHS Resource Name | Text29 | Involved | RAG | Milestone ID | Tier | Guidance | MHHS Programme Phase |
| --- | --- | --- | --- | --- | --- | --- | --- | --- | --- | --- | --- | --- | --- | --- | --- | --- | --- | --- | --- | --- | --- | --- | --- | --- | --- | --- | --- | --- |
| 1321 | 1.4.1.4.5.4.11 | **Theme 3 (Batch 1)** |  | 181d? | 2024-04-10 A | 2024-12-18 A |  | 100% |  | 2024-04-10 | 2024-12-11 | 0d |  |  |  | SI Test | SIT | -688.67 | 6.0 | Overdue Start | Steve Evans | SITAG |  |  |  |  |  |  |
| 1322 | 1.4.1.4.5.4.11.1 | Develop Test Scenarios & Test Cases (Batch 1) |  | 78d | 2024-04-10 A | 2024-07-26 A | 1194 | 100% |  | 2024-04-10 | 2024-07-26 | 46d |  |  |  | SI Test | SIT |  | 6.0 | Complete | Steve Evans | SITAG | SI Test, PP | COMPLETE |  |  |  |  |
| 1323 | 1.4.1.4.5.4.11.2 | Conclude Industry Consultation (Batch 1) |  | 11d | 2024-09-05 A | 2024-09-19 A |  | 100% |  | 2024-09-05 | 2024-09-19 | 0d |  |  | start no earlier than 2024-09-05 | SI Test | SIT |  | 6.0 | Complete | Steve Evans | SITAG |  | COMPLETE |  |  |  |  |
| 1324 | 1.4.1.4.5.4.11.3 | Review Feedback and Update |  | 5d | 2024-09-20 A | 2024-09-26 A | 1323 | 100% |  | 2024-09-20 | 2024-09-26 | 0d |  |  |  | SI Test | SIT |  | 6.0 | Complete | Steve Evans | SITAG |  | COMPLETE |  |  |  |  |
| 1325 | 1.4.1.4.5.4.11.4 | Draft Test Cases from Feedback and LLSD |  | 15d? | 2024-09-30 A | 2024-10-18 A | 1324FS+1d, 1337 | 100% |  | 2024-09-30 | 2024-10-18 | 0d |  |  |  | SI Test | SIT |  | 6.0 | Complete | Steve Evans | SITAG |  | COMPLETE |  |  |  |  |
| 1326 | 1.4.1.4.5.4.11.5 | SRO Review |  | 5d? | 2024-10-21 A | 2024-10-25 A | 1325 | 100% |  | 2024-10-21 | 2024-10-25 | 0d |  |  |  | SI Test | SIT |  | 6.0 | Complete | Steve Evans | SITAG |  | COMPLETE |  |  |  |  |
| 1327 | 1.4.1.4.5.4.11.6 | Industry Consultation |  | 10d? | 2024-10-28 A | 2024-11-08 A | 1326 | 100% |  | 2024-10-28 | 2024-11-08 | 0d |  |  |  | SI Test | SIT |  | 6.0 | Complete | Steve Evans | SITAG |  | COMPLETE |  |  |  |  |
| 1328 | 1.4.1.4.5.4.11.7 | Review Feedback and Update |  | 10d | 2024-11-11 A | 2024-11-22 A | 1327 | 100% |  | 2024-11-11 | 2024-11-15 | 0d |  |  |  | SI Test | SIT |  | 6.0 | Complete | Steve Evans | SITAG |  | COMPLETE |  |  |  |  |
| 1329 | 1.4.1.4.5.4.11.8 | SITWG paper day | milestone | 0d | 2024-11-28 A | 2024-11-28 A | 1328FS+4d | 100% |  | 2024-11-28 | 2024-11-28 |  |  |  |  |  | SIT |  | 6.13 | Complete | Steve Evans | SITAG |  | COMPLETE |  |  |  |  |
| 1330 | 1.4.1.4.5.4.11.9 | Review with SITWG (Batch 1) |  | 5d | 2024-11-29 A | 2024-12-05 A | 1329 | 100% |  | 2024-11-29 | 2024-12-05 | 0d |  |  |  | SI Test | SIT |  | 6.13 | Complete | Steve Evans | SITAG |  | COMPLETE |  |  |  |  |
| 1331 | 1.4.1.4.5.4.11.10 | SITWG endorse Theme 3 (Batch 1) | milestone | 0d | 2024-12-05 A | 2024-12-05 A | 1330 | 100% |  | 2024-12-05 | 2024-12-05 |  |  |  |  |  | SIT |  | 6.13 | Complete | Steve Evans | SITAG |  | COMPLETE |  |  |  |  |
| 1332 | 1.4.1.4.5.4.11.11 | SITAG paper day | milestone | 0d | 2024-12-11 A | 2024-12-11 A | 1331FS+4d | 100% |  | 2024-12-11 | 2024-12-11 |  |  |  |  |  | SIT |  | 6.13 | Complete | Steve Evans | SITAG |  | COMPLETE |  |  |  |  |
| 1333 | 1.4.1.4.5.4.11.12 | SITAG approve Theme 3 (Batch 1) | milestone | 0d | 2024-12-18 A | 2024-12-18 A | 1332FS+5d | 100% |  | 2024-12-18 | 2024-12-18 | 0d |  |  |  | SI Test | SIT |  | 6.13 | Complete | Steve Evans | SITAG |  | COMPLETE | T3-TE-0139 | T3 |  |  |
| 1334 | 1.4.1.4.5.4.11.13 | SIT Operational Scenarios & Test Cases Approved - Theme 3 (Batch 1 + 2) | milestone | 0d | 2024-12-18 A | 2024-12-18 A | 1337, 1320, 1333 | 100% |  | 2024-12-18 | 2024-12-18 | 0d |  |  |  | SI Test | SIT |  | 6.13 | Complete | Steve Evans | SITAG | SI Test, PP | COMPLETE | T3-TE-0119 | T3 | 31/7/24: baseline date change approved at esitag on 26/7/24 | Systems Integration Testing (SIT) |
| 1335 | 1.4.1.4.5.4.12 | **Helix SDD and LLSD Development and Approval** |  | 1d | 2024-09-27 A | 2024-09-30 A |  | 100% |  | 2024-09-27 | 2024-09-30 | 0d |  |  |  | SI Test | SIT | -688.67 | 6.0 | Overdue Start | Steve Evans | SITAG |  |  |  |  |  |  |
| 1336 | 1.4.1.4.5.4.12.1 | Development | milestone | 0d | 2024-09-27 A | 2024-09-27 A |  | 100% |  | 2024-09-27 | 2024-09-27 | 0d |  |  | start no earlier than 2024-09-27 | SI Test | SIT |  | 6.0 | Complete | Steve Evans | SITAG |  | COMPLETE |  |  |  |  |
| 1337 | 1.4.1.4.5.4.12.2 | Approval | milestone | 0d | 2024-09-30 A | 2024-09-30 A |  | 100% |  | 2024-09-30 | 2024-09-30 | 0d |  |  | start no earlier than 2024-09-30 | SI Test | SIT |  | 6.0 | Complete | Steve Evans | SITAG |  | COMPLETE |  |  |  |  |
| 1338 | 1.4.1.4.5.5 | **SIT Operational Programme RTTM** |  | 30d | 2024-12-09 A | 2025-01-17 |  | 27% | 22d | 2024-12-12 | 2025-01-17 | 0d | 32337d |  |  | SI Test | SIT | -686.67 | 6.12 | Overdue Start | Steve Evans | SITAG |  |  |  |  |  |  |
| 1339 | 1.4.1.4.5.5.1 | Develop Manual SIT Operational RTTM |  | 25d | 2024-12-09 A | 2025-01-10 | 1334FF | 32% | 17d | 2024-12-12 | 2025-01-10 | 0d | 32271d | 0d |  | SI Test | SIT |  | 6.12 | Green | Steve Evans | SITAG |  | GREEN |  |  |  |  |
| 1340 | 1.4.1.4.5.5.2 | Manual SIT Operational RTTM Complete | milestone | 0d | 2025-01-10 | 2025-01-10 | 1339 |  |  | 2025-01-10 | 2025-01-10 | 0d | 32271d | 0d |  | SI Test | SIT | 21.71 | 6.12 | Green | Steve Evans | SITAG |  | GREEN |  |  |  |  |
| 1341 | 1.4.1.4.5.5.3 | Develop Automated SIT Operational RTTM |  | 5d | 2025-01-13 | 2025-01-17 | 1339 |  |  | 2025-01-13 | 2025-01-17 | 0d | 32337d | 0d |  | SI Test | SIT | 24.33 | 6.12 | Green | Steve Evans | SITAG |  | GREEN |  |  |  |  |
| 1342 | 1.4.1.4.5.5.4 | Automated SIT Operational RTTM Complete | milestone | 0d | 2025-01-17 | 2025-01-17 | 1341 |  |  | 2025-01-17 | 2025-01-17 | 0d | 32337d |  |  | SI Test | SIT | 28.71 | 6.12 | Green | Steve Evans | SITAG |  | GREEN |  |  |  |  |
| 1343 | 1.4.1.4.5.6 | **Theme 3 Work-off plan** |  | 76d? | 2025-01-06 | 2025-04-21 |  |  |  | 2025-02-17 | 2025-05-01 | 0d | 32271d |  |  | SI Test | SIT | -693.67 | 6.13 | Overdue Start | Steve Evans | SITAG |  |  |  |  |  |  |
| 1344 | 1.4.1.4.5.6.1 | Test Scripts updates |  | 52d | 2025-01-13 | 2025-03-25 | 1340 |  |  | 2025-04-08 | 2025-04-08 | 0d | 32271d | 0d |  | SI Test | SIT | 24.33 | 6.13 | Green | Steve Evans | SITAG |  | GREEN |  |  |  |  |
| 1345 | 1.4.1.4.5.6.2 | RTTM Updated Additional Static RTTM WBS items |  | 10d | 2025-03-26 | 2025-04-08 | 1344 |  |  | 2025-04-07 | 2025-04-18 | 0d | 32271d | 0d |  | SI Test | SIT | 96.33 | 6.13 | Green | Steve Evans | SITAG |  | GREEN |  |  |  |  |
| 1346 | 1.4.1.4.5.6.3 | Removal of de-scoped TCs from the RTTMs |  | 5d | 2025-04-02 | 2025-04-08 | 1345FS-5d |  |  | 2025-04-14 | 2025-04-18 | 0d | 32280d |  |  | SI Test | SIT | 103.33 | 6.13 | Green | Steve Evans | SITAG |  | GREEN |  |  |  |  |
| 1347 | 1.4.1.4.5.6.4 | Update and stabilisation of all TC ADO IDs |  | 14d | 2025-04-02 | 2025-04-21 | 1345FS-5d |  |  | 2025-04-14 | 2025-05-01 | 0d | 32271d |  |  | SI Test | SIT | 103.33 | 6.13 | Green | Heath Thomas | SITAG |  | GREEN |  |  |  |  |
| 1348 | 1.4.1.4.5.6.5 | Addition and integration of Role tags to reqs in the Role RTTMs |  | 5d | 2025-04-02 | 2025-04-08 | 1345FS-5d |  |  | 2025-04-14 | 2025-04-18 | 0d | 32280d |  |  | SI Test | SIT | 103.33 | 6.13 | Green | Salman Bukhari | SITAG |  | GREEN |  |  |  |  |
| 1349 | 1.4.1.4.5.6.6 | Update of the RTTM All sheet (porting of the individual RTTMs) |  | 7d | 2025-04-07 | 2025-04-15 | 1345FS-2d |  |  | 2025-04-17 | 2025-04-25 | 0d | 32273d | 0d |  | SI Test | SIT | 108.33 | 6.13 | Green | Salman Bukhari | SITAG |  | GREEN |  |  |  |  |
| 1350 | 1.4.1.4.5.6.7 | Define Additional ADO Tags |  | 1d | 2025-04-04 | 2025-04-04 | 1345FS-3d |  |  | 2025-04-16 | 2025-04-16 | 0d | 32282d |  |  | SI Test | SIT | 105.33 | 6.13 | Green | Steve Evans | SITAG |  | GREEN |  |  |  |  |
| 1351 | 1.4.1.4.5.6.8 | Upload Operational RTTM to ADO | milestone | 0d | 2025-04-15 | 2025-04-15 | 1349 |  |  | 2025-04-25 | 2025-04-25 | 0d | 32275d |  |  | SI Test | SIT | 116.71 | 6.13 | Green | Heath Thomas | SITAG |  | GREEN |  |  |  |  |
| 1352 | 1.4.1.4.5.6.9 | Further Interative Deepdive on the requirements to testcase mapping |  | 9d | 2025-04-02 | 2025-04-14 | 1349FS-10d |  |  | 2025-04-14 | 2025-04-24 | 0d | 32273d | 0d |  | SI Test | SIT | 103.33 | 6.13 | Green | Steve Evans | SITAG |  | GREEN |  |  |  |  |
| 1353 | 1.4.1.4.5.6.10 | Internal review |  | 5d | 2025-04-02 | 2025-04-08 | 1352FS-9d |  |  | 2025-04-14 | 2025-04-18 | 0d | 32273d | 0d |  | SI Test | SIT | 103.33 | 6.13 | Green | Steve Evans | SITAG |  | GREEN |  |  |  |  |
| 1354 | 1.4.1.4.5.6.11 | Issue Static RTTM to Code Bodies |  | 1d? | 2025-04-10 | 2025-04-10 | 1353FS+1d |  |  | 2025-04-22 | 2025-04-22 | 0d | 32273d | 0d |  | SI Test | SIT | 111.33 | 6.13 | Green | Steve Evans | SITAG |  | GREEN |  |  |  |  |
| 1355 | 1.4.1.4.5.6.12 | Code Body Acceptance of RTTM |  | 5d | 2025-04-11 | 2025-04-17 | 1354 |  |  | 2025-04-23 | 2025-04-29 | 0d | 32273d |  |  | Code Bodies | SIT | 112.33 | 6.13 | Green | Steve Evans | SITAG |  | GREEN |  |  |  |  |

Notes:
- 1341: 18/12/24 - Programme and SRO still agreeing a definition of the automated RTTM, action can't be completed until this is done.
- 1342: 18/12/24 - Programme and SRO still agreeing a definition of the automated RTTM, action can't be completed until this is done.
- 1343: 19/12/24 - Programme due to revisit and update these dates.
- 1344: 19/12/24 - Programme due to revisit and update these dates.
- 1345: 19/12/24 - Programme due to revisit and update these dates.
- 1346: 19/12/24 - Programme due to revisit and update these dates.
- 1347: 19/12/24 - Programme due to revisit and update these dates.
- 1348: 19/12/24 - Programme due to revisit and update these dates.
- 1349: 19/12/24 - Programme due to revisit and update these dates.
- 1350: 19/12/24 - Programme due to revisit and update these dates.
- 1351: 19/12/24 - Programme due to revisit and update these dates.
- 1352: 19/12/24 - Programme due to revisit and update these dates.
- 1353: 19/12/24 - Programme due to revisit and update these dates.
- 1354: 19/12/24 - Programme due to revisit and update these dates.
- 1355: 19/12/24 - Programme due to revisit and update these dates.

| ID | WBS | Task | Type | Duration | Start | Finish | Predecessors | Complete | Remaining | Baseline start | Baseline finish | Baseline duration | Baseline 1 start | Baseline 1 finish | Total slack | Free slack | Constraint | Baseline cost | Responsible | Text9 | Task Status | Update Version | Sched Status | MHHS Resource Name | Text29 | RAG | Involved | MHHS Programme Phase |
| --- | --- | --- | --- | --- | --- | --- | --- | --- | --- | --- | --- | --- | --- | --- | --- | --- | --- | --- | --- | --- | --- | --- | --- | --- | --- | --- | --- | --- |
| 1356 | 1.4.1.4.5.6.13 | **SIT Operational DITL** |  | 18d | 2025-01-06 | 2025-01-29 |  |  |  | 2024-10-08 | 2024-10-17 | 0d |  |  | 32329d |  |  |  | SI Test | SIT | 6.33 | 6.15 | No BL | Dom Mooney | SITAG |  |  |  |
| 1357 | 1.4.1.4.5.6.13.1 | DITL Development |  | 10d | 2025-01-06 | 2025-01-17 |  |  |  | 2025-01-06 | 2025-01-17 | 0d |  |  | 32329d | 0d | start no earlier than 2025-01-06 |  | SI Test | SIT | 17.33 | 6.15 | Green | Dom Mooney | SITAG | GREEN |  |  |
| 1358 | 1.4.1.4.5.6.13.2 | SRO Review |  | 5d | 2025-01-20 | 2025-01-24 | 1357 |  |  | 2025-01-20 | 2025-01-24 | 0d |  |  | 32329d | 0d |  |  | SI Test | SIT | 31.33 | 6.15 | Green | Dom Mooney | SITAG | GREEN |  |  |
| 1359 | 1.4.1.4.5.6.13.3 | Post-SRO Review Changes |  | 3d | 2025-01-27 | 2025-01-29 | 1358 |  |  | 2025-01-27 | 2025-01-29 | 0d |  |  | 32329d | 0d |  |  | SI Test | SIT | 38.33 | 6.15 | Green | Dom Mooney | SITAG | GREEN |  |  |
| 1360 | 1.4.1.4.5.6.13.4 | Publish Cycle 3 DITL / Cycle 3 DITL Online Sessions for SIT PPs | milestone | 0d | 2025-01-29 | 2025-01-29 | 1359 |  |  | 2025-01-29 | 2025-01-29 | 0d |  |  | 32329d |  |  |  | SI Test | SIT | 40.71 | 6.15 | Green | Dom Mooney | SITAG | GREEN |  |  |
| 1361 | 1.4.1.4.5.7 | **Environments (SIT B)** |  | 0d | 2024-10-07 A | 2024-10-07 A |  | 100% |  | 2024-10-07 | 2024-10-07 | 0d | 2024-09-03 | 2024-09-09 |  |  |  | -0 | N/A | SIT |  | 5.0 |  | Heath Thomas | SITAG |  | N/A | Systems Integration Testing (SIT) |
| 1362 | 1.4.1.4.5.7.1 | **PP Environments (SIT B)** |  | 0d | 2024-10-07 A | 2024-10-07 A |  | 100% |  | 2024-10-07 | 2024-10-07 | 0d | 2024-09-03 | 2024-09-09 |  |  |  | -0 | N/A | SIT |  | 5.0 |  | Heath Thomas | SITAG |  | N/A | Systems Integration Testing (SIT) |
| 1363 | 1.4.1.4.5.7.1.1 | Deployment of MHHS solution code to SIT B environments | milestone | 0d | 2024-10-07 A | 2024-10-07 A | 141 | 100% |  | 2024-10-07 | 2024-10-07 | 0d | 2024-09-03 | 2024-09-09 |  |  | start no earlier than 2024-08-27 |  | PP | SIT |  | 5.21 | Complete | Heath Thomas | SITAG | COMPLETE | SI Test | Systems Integration Testing (SIT) |
| 1364 | 1.4.1.4.5.7.2 | **SI Environments (SIT B)** |  | 0d | 2024-10-07 A | 2024-10-07 A |  | 100% |  | 2024-10-07 | 2024-10-07 | 0d | 2024-09-03 | 2024-09-09 |  |  |  | -0 | N/A | SIT |  | 5.0 |  | Heath Thomas | SITAG |  | N/A | Systems Integration Testing (SIT) |
| 1365 | 1.4.1.4.5.7.2.1 | Coordinate deployment of MHHS solution code to SIT Participants' SIT B environments | milestone | 0d | 2024-10-07 A | 2024-10-07 A | 1363SS | 100% |  | 2024-10-07 | 2024-10-07 | 0d | 2024-09-03 | 2024-09-09 |  |  |  |  | SI Test | SIT |  | 5.21 | Complete | Heath Thomas | SITAG | COMPLETE | PP | Systems Integration Testing (SIT) |
| 1366 | 1.4.1.4.6 | **SIT Operational Overarching Test Readiness Reports** |  | 33d? | 2024-08-05 A | 2024-09-18 |  | 2% | 32.39d? | 2024-08-05 | 2024-09-18 | 151d | 2025-01-07 | 2025-03-03 |  |  |  | -0 | N/A | SIT |  | 6.0 |  | Steve Evans | SITAG |  | N/A | Systems Integration Testing (SIT) |
| 1367 | 1.4.1.4.6.1 | **SI SIT Operational Theme 3 (Batch 1) Overarching Test Readiness Report** |  | 28d | 2024-12-23 | 2025-01-29 |  |  |  | 2024-12-23 | 2025-01-29 |  |  |  | 32328d |  |  |  |  | SIT | -135.67 | 6.15 | Overdue Start |  |  | RED |  |  |
| 1368 | 1.4.1.4.6.1.1 | Develop Overarching SIT Operational Theme 3 (Batch 1) Overarching Test Readiness Report |  | 18d | 2024-12-23 | 2025-01-15 | 414 |  |  | 2024-12-23 | 2025-01-15 |  |  |  | 32328d | 0d |  |  |  | SIT | 3.33 | 6.15 | Green |  |  | GREEN |  |  |
| 1369 | 1.4.1.4.6.1.2 | SRO review |  | 5d | 2025-01-16 | 2025-01-22 | 1368 |  |  | 2025-01-16 | 2025-01-22 |  |  |  | 32328d | 0d |  |  |  | SIT | 27.33 | 6.15 | Green |  |  | GREEN |  |  |
| 1370 | 1.4.1.4.6.1.3 | Update Operational Theme 3 (Batch 1) Overarching Test Readiness Report following SRO feedback |  | 5d | 2025-01-16 | 2025-01-22 | 1369FF, 1307FF |  |  | 2025-01-16 | 2025-01-22 |  |  |  | 32328d | 0d |  |  |  | SIT | 27.33 | 6.15 | Green |  |  | GREEN |  |  |
| 1371 | 1.4.1.4.6.1.4 | SITAG paper day | milestone | 0d | 2025-01-22 | 2025-01-22 | 1370 |  |  | 2025-01-22 | 2025-01-22 |  |  |  | 32328d | 0d |  |  |  | SIT | 33.71 | 6.15 | Green |  |  | GREEN |  |  |
| 1372 | 1.4.1.4.6.1.5 | SITAG approve Theme 3 (Batch 1) Theme 1 Test Readiness Report | milestone | 0d | 2025-01-29 | 2025-01-29 | 1371FS+5d |  |  | 2025-01-29 | 2025-01-29 |  |  |  | 32328d | 0d |  |  |  | SIT | 40.71 | 6.15 | Green |  |  | GREEN |  |  |
| 1373 | 1.4.1.4.6.2 | **SI SIT Operational Theme 1, 2 and 3 (Batch 2) Overarching Test Readiness Report** |  | 45d | 2025-01-27 | 2025-03-28 |  |  |  | 2025-01-27 | 2025-03-28 |  |  |  | 31603d |  |  |  |  | SIT | -135.67 | 6.15 | Overdue Start |  |  | RED |  |  |
| 1374 | 1.4.1.4.6.2.1 | Develop Overarching SIT Operational Theme 1, 2 and 3 (Batch 2) Overarching Test Readiness Report |  | 20d | 2025-01-27 | 2025-02-21 | 397FS+25d |  |  | 2025-01-27 | 2025-02-21 |  |  |  | 31610d | 0d | start no earlier than 2025-01-20 |  |  | SIT | 38.33 | 6.15 | Green |  |  | GREEN |  |  |
| 1375 | 1.4.1.4.6.2.2 | SRO review |  | 5d | 2025-02-24 | 2025-02-28 | 1374 |  |  | 2025-02-24 | 2025-02-28 |  |  |  | 31610d | 0d |  |  |  | SIT | 66.33 | 6.15 | Green |  |  | GREEN |  |  |
| 1376 | 1.4.1.4.6.2.3 | Update Operational Theme 1, 2 and 3 (Batch 2) Overarching Test Readiness Report following SRO feedback |  | 8d | 2025-03-03 | 2025-03-12 | 1375 |  |  | 2025-03-03 | 2025-03-12 |  |  |  | 31610d | 0d |  |  |  | SIT | 73.33 | 6.15 | Green |  |  | GREEN |  |  |
| 1377 | 1.4.1.4.6.2.4 | SITAG paper day | milestone | 0d | 2025-03-12 | 2025-03-12 | 1376 |  |  | 2025-03-12 | 2025-03-12 |  |  |  | 31610d | 0d |  |  |  | SIT | 82.71 | 6.15 | Green |  |  | GREEN |  |  |
| 1378 | 1.4.1.4.6.2.5 | SITAG endorse Operational Theme 1, 2 and 3 (Batch 2) Overarching Test Readiness Report | milestone | 0d | 2025-03-19 | 2025-03-19 | 1377FS+5d |  |  | 2025-03-19 | 2025-03-19 |  |  |  | 31610d | 7d |  |  |  | SIT | 89.71 | 6.15 | Green |  |  | GREEN |  |  |
| 1379 | 1.4.1.4.6.2.6 | eSITAG approve Operational Theme 1, 2 and 3 (Batch 2) Overarching Test Readiness Report | milestone | 0d | 2025-03-28 | 2025-03-28 | 1378, 1147, 1148 |  |  | 2025-03-28 | 2025-03-28 |  |  |  | 31603d | 0d |  |  |  | SIT | 98.71 | 6.15 | Green |  |  | GREEN |  |  |

| ID | WBS | Task | Type | Duration | Start | Finish | Predecessors | Complete | Remaining | Baseline start | Baseline finish | Baseline duration | Baseline 1 start | Baseline 1 finish | Total slack | Free slack | Constraint | Responsible | Text9 | Task Status | Update Version | Sched Status | MHHS Resource Name | RAG | Text29 | Milestone ID | Involved | MHHS Programme Phase | Tier |
| --- | --- | --- | --- | --- | --- | --- | --- | --- | --- | --- | --- | --- | --- | --- | --- | --- | --- | --- | --- | --- | --- | --- | --- | --- | --- | --- | --- | --- | --- |
| 1380 | 1.4.1.4.6.3 | **SIT Operational Execution Model** |  | 43d | 2024-08-05 | 2024-10-02 |  |  |  | 2024-08-05 | 2024-10-02 | 0d |  |  |  |  |  | SI Test | SIT | -134.67 | 6.15 | Overdue Start | Steve Evans | RED | SITAG |  |  |  |  |
| 1381 | 1.4.1.4.6.3.1 | **Theme 3 (Batch 1)** |  | 27d | 2024-08-05 | 2024-09-10 |  |  |  | 2024-08-05 | 2024-09-10 | 0d |  |  |  |  |  | SI Test | SIT | -134.67 | 6.15 | Overdue Start | Steve Evans | RED | SITAG |  |  |  |  |
| 1382 | 1.4.1.4.6.3.1.1 | Develop execution model Theme 3 (Batch 1) |  | 3d | 2024-12-16 | 2024-12-18 | 1334FF |  |  | 2024-12-16 | 2024-12-18 | 0d |  |  | 32335d | 0d |  | SI Test | SIT | -3.67 | 6.15 | Green | Steve Evans | GREEN | SITAG |  |  |  |  |
| 1383 | 1.4.1.4.6.3.1.2 | SRO provide feedback |  | 14d | 2024-12-19 | 2025-01-07 | 1382 |  |  | 2024-12-19 | 2025-01-07 | 0d |  |  | 32335d | 0d |  | SI Test | SIT | -0.67 | 6.15 | Green | Steve Evans | GREEN | SITAG |  |  |  |  |
| 1384 | 1.4.1.4.6.3.1.3 | Address SRO feedback on execution model |  | 2d | 2025-01-08 | 2025-01-09 | 1383 |  |  | 2025-01-08 | 2025-01-09 | 0d |  |  | 32335d | 0d |  | SI Test | SIT | 19.33 | 6.15 | Green | Steve Evans | GREEN | SITAG |  |  |  |  |
| 1385 | 1.4.1.4.6.3.1.4 | Finalise execution model |  | 3d | 2025-01-10 | 2025-01-14 | 1384 |  |  | 2025-01-10 | 2025-01-14 | 0d |  |  | 32335d | 0d |  | SI Test | SIT | 21.33 | 6.15 | Green | Steve Evans | GREEN | SITAG |  |  |  |  |
| 1386 | 1.4.1.4.6.3.1.5 | SITWG paper day | milestone | 0d | 2025-01-14 | 2025-01-14 | 1385 |  |  | 2025-01-14 | 2025-01-14 | 0d |  |  | 32335d | 0d |  | SI Test | SIT | 25.71 | 6.15 | Green | Steve Evans | GREEN | SITAG |  |  |  |  |
| 1387 | 1.4.1.4.6.3.1.6 | SITWG update on execution model | milestone | 0d | 2025-01-21 | 2025-01-21 | 1386FS+5d |  |  | 2025-01-21 | 2025-01-21 | 0d |  |  | 32335d |  |  | SI Test | SIT | 32.71 | 6.15 | Green | Steve Evans | GREEN | SITAG |  |  |  |  |
| 1388 | 1.4.1.4.6.3.2 | **Theme 1, 2 and 3 (Batch 2)** |  | 23d | 2024-08-05 | 2024-09-04 |  |  |  | 2024-08-05 | 2024-09-04 | 0d |  |  |  |  |  | SI Test | SIT | -134.67 | 6.15 | Overdue Start | Steve Evans | RED | SITAG |  |  |  |  |
| 1389 | 1.4.1.4.6.3.2.1 | Develop execution model Theme 1, 2 and 3 (Batch 2) |  | 3d | 2025-01-13 | 2025-01-15 | 1334 |  |  | 2025-01-13 | 2025-01-15 | 0d |  |  | 32319d | 0d | start no earlier than 2025-01-13 | SI Test | SIT | 24.33 | 6.15 | Green | Steve Evans | GREEN | SITAG |  |  |  |  |
| 1390 | 1.4.1.4.6.3.2.2 | SRO provide feedback |  | 5d | 2025-01-16 | 2025-01-22 | 1389 |  |  | 2025-01-16 | 2025-01-22 | 0d |  |  | 32319d | 0d |  | SI Test | SIT | 27.33 | 6.15 | Green | Steve Evans | GREEN | SITAG |  |  |  |  |
| 1391 | 1.4.1.4.6.3.2.3 | Address SRO feedback on execution model |  | 2d | 2025-01-23 | 2025-01-24 | 1390 |  |  | 2025-01-23 | 2025-01-24 | 0d |  |  | 32319d | 0d |  | SI Test | SIT | 34.33 | 6.15 | Green | Steve Evans | GREEN | SITAG |  |  |  |  |
| 1392 | 1.4.1.4.6.3.2.4 | Finalise execution model |  | 3d | 2025-01-27 | 2025-01-29 | 1391 |  |  | 2025-01-27 | 2025-01-29 | 0d |  |  | 32319d | 0d |  | SI Test | SIT | 38.33 | 6.15 | Green | Steve Evans | GREEN | SITAG |  |  |  |  |
| 1393 | 1.4.1.4.6.3.2.5 | SITWG paper day | milestone | 0d | 2025-02-05 | 2025-02-05 | 1392FS+5d |  |  | 2025-02-05 | 2025-02-05 | 0d |  |  | 32319d | 0d |  | SI Test | SIT | 47.71 | 6.15 | Green | Steve Evans | GREEN | SITAG |  |  |  |  |
| 1394 | 1.4.1.4.6.3.2.6 | SITWG update on execution model | milestone | 0d | 2025-02-12 | 2025-02-12 | 1393FS+5d |  |  | 2025-02-12 | 2025-02-12 | 0d |  |  | 32319d |  |  | SI Test | SIT | 54.71 | 6.15 | Green | Steve Evans | GREEN | SITAG |  |  |  |  |
| 1395 | 1.4.1.4.6.4 | **SIT Operational Theme 3 (Batch 1) progress reporting** |  | 29d? | 2024-12-19 A | 2025-01-28 |  | 17% | 24.17d? | 2024-12-19 | 2025-01-31 | 0d |  |  |  |  |  | SI Test | SIT | -94.67 | 6.14 | Overdue Start | Steve Evans | RED | SITAG |  |  |  |  |
| 1396 | 1.4.1.4.6.4.1 | Determine reporting methodology |  | 2d? | 2024-12-19 A | 2024-12-20 A |  | 100% |  | 2024-12-19 | 2025-01-17 | 0d |  |  |  |  |  | SI Test | SIT |  | 6.14 | Complete | Steve Evans | COMPLETE | SITAG |  |  |  |  |
| 1397 | 1.4.1.4.6.4.2 | Implement reporting |  | 10d | 2024-12-23 | 2025-01-03 | 1396 |  |  | 2025-01-20 | 2025-01-31 | 0d |  |  | 32347d |  |  | SI Test | SIT | 3.33 | 6.14 | Green | Steve Evans | GREEN | SITAG |  |  |  |  |
| 1398 | 1.4.1.4.6.5 | SIT Operational Theme 3 (Batch 1) Testing Preparation Complete | milestone | 0d | 2025-01-30 | 2025-01-30 | 1372FS+1d, 1307 |  |  | 2025-01-17 | 2025-01-17 |  |  |  | 32328d |  |  |  | SIT | 41.71 | 6.15 | yellow |  | RED |  | T2-TE-0750 |  |  |  |
| 1399 | 1.4.1.4.6.6 | SIT Operational Theme 1, 2, 3 (Batch 2) Testing Preparation Complete | milestone | 0d | 2025-03-28 | 2025-03-28 | 415, 1207, 1213, 1334, 1379 |  |  | 2025-03-31 | 2025-04-25 | 0d | 2025-03-10 | 2025-03-10 | 31604d | 1d | finish no earlier than 2024-10-04 | SI Test | SIT | 98.71 | 6.15 | Green | Roger Robar | GREEN | SITAG | T2-TE-1300 | PP,IPA | Systems Integration Testing (SIT) | T2 |
| 1400 | 1.4.1.4.7 | **Regression Test Preparation** |  | 2d? | 2024-11-18 A | 2024-11-19 |  | 10% | 1.8d? | 2024-09-16 | 2025-05-16 | 0d |  |  |  |  |  | SI Test | SIT | -686.67 | 6.15 | Overdue Start | Roger Robar |  | SITAG |  |  |  |  |
| 1401 | 1.4.1.4.7.1 | **Regression Test Approach** |  | 10d | 2024-11-18 A | 2024-11-29 |  | 26% | 7.41d | 2024-09-16 | 2024-11-20 | 0d |  |  |  |  |  | SI Test | SIT | -686.67 | 6.15 | Overdue Start | Roger Robar |  | SITAG |  |  |  |  |
| 1402 | 1.4.1.4.7.1.1 | Develop approach doc |  | 15d | 2024-11-18 A | 2024-12-06 A |  | 100% |  | 2024-11-18 | 2024-12-13 | 0d |  |  |  |  | start no earlier than 2024-09-16 | SI Test | SIT |  | 6.15 | Complete | Roger Robar | COMPLETE |  |  |  |  |  |
| 1403 | 1.4.1.4.7.1.2 | SRO / LDP review of approach doc |  | 10d | 2024-12-09 A | 2024-12-20 | 1402 | 3% | 9.7d | 2024-12-16 | 2024-12-18 | 0d |  |  | 31614d | 0d |  | SI Test | SIT |  | 6.15 | yellow | Roger Robar | RED |  |  |  |  |  |
| 1404 | 1.4.1.4.7.1.3 | Incorporate SRO feedback into approach doc |  | 15d | 2024-12-23 | 2025-01-10 | 1403 |  |  | 2024-12-19 | 2024-12-20 | 0d |  |  | 31614d | 0d |  | SI Test | SIT | 3.33 | 6.15 | Red | Roger Robar | RED |  |  |  |  |  |
| 1405 | 1.4.1.4.7.1.4 | Industry review of approach |  | 10d | 2025-01-20 | 2025-01-31 | 1404FS+5d |  |  | 2025-01-20 | 2025-01-31 |  |  |  | 31614d | 0d |  |  | SIT | 31.33 | 6.15 | Green |  | GREEN |  |  |  |  |  |
| 1406 | 1.4.1.4.7.1.5 | Updates to approach doc on back of industry feedback |  | 7d | 2025-02-03 | 2025-02-11 | 1405 |  |  | 2025-02-03 | 2025-02-11 |  |  |  | 31614d | 0d |  |  | SIT | 45.33 | 6.15 | Green |  | GREEN |  |  |  |  |  |
| 1407 | 1.4.1.4.7.1.6 | eSITWG paper day | milestone | 0d | 2025-02-11 | 2025-02-11 | 1406 |  |  | 2024-12-20 | 2024-12-20 | 0d |  |  | 31614d | 0d |  | SI Test | SIT | 53.71 | 6.15 | Red | Roger Robar | RED |  |  |  |  |  |
| 1408 | 1.4.1.4.7.1.7 | eSITWG Recommendation | milestone | 0d | 2025-02-18 | 2025-02-18 | 1407FS+5d |  |  | 2025-01-08 | 2025-01-08 | 0d |  |  | 32308d | 0d | start no earlier than 2025-01-20 | SI Test | SIT | 60.71 | 6.15 | Red | Roger Robar | RED |  |  |  |  |  |
| 1409 | 1.4.1.4.7.1.8 | Incorporate eSITWG feedback into approach doc |  | 2d | 2025-02-19 | 2025-02-20 | 1408 |  |  | 2025-01-09 | 2025-01-09 | 0d |  |  | 32308d | 0d |  | SI Test | SIT | 61.33 | 6.15 | Red | Roger Robar | RED |  |  |  |  |  |
| 1410 | 1.4.1.4.7.1.9 | eSITAG paper day | milestone | 0d | 2025-02-20 | 2025-02-20 | 1409 |  |  | 2025-01-09 | 2025-01-09 | 0d |  |  | 32308d | 0d |  | SI Test | SIT | 62.71 | 6.15 | Red | Roger Robar | RED |  |  |  |  |  |
| 1411 | 1.4.1.4.7.1.10 | eSITAG (inc SRO) Approval | milestone | 0d | 2025-02-27 | 2025-02-27 | 1410FS+5d |  |  | 2025-01-16 | 2025-01-16 | 0d |  |  | 32308d | 0d |  | SI Test | SIT | 69.71 | 6.15 | Red | Roger Robar | RED |  |  |  |  |  |
| 1412 | 1.4.1.4.7.1.11 | SIT Regression Testing Approach and Plan Approval | milestone | 0d | 2025-02-27 | 2025-02-27 | 1411 |  |  | 2025-01-16 | 2025-01-16 | 0d |  |  | 32308d |  |  | SI Test | SIT | 69.71 | 6.15 | Red | Roger Robar | RED | SITAG | T3-TE-0123 |  |  | T3 |

Notes:
- 1401: 18/12/24 - Programme walked through the proposed updates to Regression plan at Dec SITAG. Due to return to Jan SITAG to formally approve and rebaseline this date.
- 1402: 18/12/24 - Programme walked through the proposed updates to Regression plan at Dec SITAG. Due to return to Jan SITAG to formally approve and rebaseline this date.
- 1403: 18/12/24 - Programme walked through the proposed updates to Regression plan at Dec SITAG. Due to return to Jan SITAG to formally approve and rebaseline this date.
- 1404: 18/12/24 - Programme walked through the proposed updates to Regression plan at Dec SITAG. Due to return to Jan SITAG to formally approve and rebaseline this date.
- 1405: 18/12/24 - Programme walked through the proposed updates to Regression plan at Dec SITAG. Due to return to Jan SITAG to formally approve and rebaseline this date.
- 1406: 18/12/24 - Programme walked through the proposed updates to Regression plan at Dec SITAG. Due to return to Jan SITAG to formally approve and rebaseline this date.
- 1407: 18/12/24 - Programme walked through the proposed updates to Regression plan at Dec SITAG. Due to return to Jan SITAG to formally approve and rebaseline this date.
- 1408: 18/12/24 - Programme walked through the proposed updates to Regression plan at Dec SITAG. Due to return to Jan SITAG to formally approve and rebaseline this date.
- 1409: 18/12/24 - Programme walked through the proposed updates to Regression plan at Dec SITAG. Due to return to Jan SITAG to formally approve and rebaseline this date.
- 1410: 18/12/24 - Programme walked through the proposed updates to Regression plan at Dec SITAG. Due to return to Jan SITAG to formally approve and rebaseline this date.
- 1411: 18/12/24 - Programme walked through the proposed updates to Regression plan at Dec SITAG. Due to return to Jan SITAG to formally approve and rebaseline this date.
- 1412: 18/12/24 - Programme walked through the proposed updates to Regression plan at Dec SITAG. Due to return to Jan SITAG to formally approve and rebaseline this date.

| ID | WBS | Task | Type | Duration | Start | Finish | Predecessors | Complete | Remaining | Baseline start | Baseline finish | Baseline duration | Total slack | Free slack | Constraint | Responsible | Text9 | Task Status | Update Version | Sched Status | MHHS Resource Name | RAG | Milestone ID | Programme Governance Forum responsible for decisio | Text29 | Tier |
| --- | --- | --- | --- | --- | --- | --- | --- | --- | --- | --- | --- | --- | --- | --- | --- | --- | --- | --- | --- | --- | --- | --- | --- | --- | --- | --- |
| 1413 | 1.4.1.4.7.2 | **Regression Test Suite** |  | 57d | 2025-02-12 | 2025-05-01 |  |  |  | 2025-01-17 | 2025-03-18 | 0d | 31614d |  |  | SI Test | SIT | -686.67 | 6.15 | Overdue Start | Roger Robar |  |  |  |  |  |
| 1414 | 1.4.1.4.7.2.1 | Build Regression Test Suite |  | 23d | 2025-02-12 | 2025-03-14 | 1407 |  |  | 2025-01-17 | 2025-02-06 | 0d | 31614d | 0d |  | SI Test | SIT | 54.33 | 6.15 | Red | Roger Robar | RED |  |  |  |  |
| 1415 | 1.4.1.4.7.2.2 | LDP review of Regression Test Suite |  | 2d | 2025-03-17 | 2025-03-18 | 1414 |  |  | 2025-03-17 | 2025-03-18 |  | 31614d | 0d |  |  | SIT | 87.33 | 6.15 | Green |  | GREEN |  |  |  |  |
| 1416 | 1.4.1.4.7.2.3 | SRO Review of regression suite doc |  | 5d | 2025-03-19 | 2025-03-25 | 1415 |  |  | 2025-02-07 | 2025-02-20 | 0d | 31614d | 0d |  | SI Test | SIT | 89.33 | 6.15 | Red | Roger Robar | RED |  |  |  |  |
| 1417 | 1.4.1.4.7.2.4 | Incorporate SRO feedback into regression suite doc |  | 3d | 2025-03-26 | 2025-03-28 | 1416 |  |  | 2025-02-21 | 2025-02-27 | 0d | 31614d | 0d |  | SI Test | SIT | 96.33 | 6.15 | Red | Roger Robar | RED |  |  |  |  |
| 1418 | 1.4.1.4.7.2.5 | Industry review of Regression Test Suite |  | 10d | 2025-03-31 | 2025-04-11 | 1417 |  |  | 2025-03-31 | 2025-04-11 |  | 31614d | 0d |  |  | SIT | 101.33 | 6.15 | Green |  | GREEN |  |  |  |  |
| 1419 | 1.4.1.4.7.2.6 | Incorporate Industry feedback into regression suite doc |  | 3d | 2025-04-14 | 2025-04-16 | 1418 |  |  | 2025-04-14 | 2025-04-16 |  | 31614d | 0d |  |  | SIT | 115.33 | 6.15 | Green |  | GREEN |  |  |  |  |
| 1420 | 1.4.1.4.7.2.7 | eSITWG paper day | milestone | 0d | 2025-04-16 | 2025-04-16 | 1419 |  |  | 2025-02-27 | 2025-02-27 | 0d | 31614d | 0d |  | SI Test | SIT | 117.71 | 6.15 | Red | Roger Robar | RED |  |  |  |  |
| 1421 | 1.4.1.4.7.2.8 | eSITWG endorses regression suite doc | milestone | 0d | 2025-04-23 | 2025-04-23 | 1420FS+5d |  |  | 2025-03-06 | 2025-03-06 | 0d | 31614d | 0d |  | SI Test | SIT | 124.71 | 6.15 | Red | Roger Robar | RED |  |  |  |  |
| 1422 | 1.4.1.4.7.2.9 | Incorporate SITWG feedback into regression suite doc |  | 1d | 2025-04-24 | 2025-04-24 | 1421 |  |  | 2025-03-07 | 2025-03-11 | 0d | 31614d | 0d |  | SI Test | SIT | 125.33 | 6.15 | Red | Roger Robar | RED |  |  |  |  |
| 1423 | 1.4.1.4.7.2.10 | eSITAG paper day | milestone | 0d | 2025-04-24 | 2025-04-24 | 1422 |  |  | 2025-03-11 | 2025-03-11 | 0d | 31614d | 0d |  | SI Test | SIT | 125.71 | 6.15 | Red | Roger Robar | RED |  |  |  |  |
| 1424 | 1.4.1.4.7.2.11 | eSITAG (inc SRO) Approval of regression suite doc | milestone | 0d | 2025-05-01 | 2025-05-01 | 1423FS+5d |  |  | 2025-03-18 | 2025-03-18 | 0d | 32263d | 0d |  | SI Test | SIT | 132.71 | 6.15 | Red | Roger Robar | RED |  |  |  |  |
| 1425 | 1.4.1.4.7.2.12 | SIT Regression Approval | milestone | 0d | 2025-05-01 | 2025-05-01 | 1424 |  |  | 2025-03-18 | 2025-03-18 | 0d | 32263d |  |  | SI Test | SIT | 132.71 | 6.15 | Red | Roger Robar | RED | T3-TE-0122 | SITAG | SITAG | T3 |
| 1426 | 1.4.1.4.7.3 | **Regression Test Data Load Window (SIT Functional and Migration) - SIT A** |  | 1d? | 2025-04-28 | 2025-04-29 |  |  |  | 2025-03-14 | 2025-03-17 | 0d |  |  |  | SI Test | SIT | -686.67 | 6.15 | Overdue Start | Richard Puddephatt |  |  |  |  |  |
| 1427 | 1.4.1.4.7.3.1 | Data Load preparation activities |  | 30d? | 2025-03-05 | 2025-04-15 |  |  |  | 2025-03-05 | 2025-04-15 | 0d | 36d | 9d | start no earlier than 2025-03-05 | SI Test | SIT | 75.33 | 6.15 | Green |  | GREEN |  |  |  |  |
| 1428 | 1.4.1.4.7.3.2 | Regression Test Data Load Start | milestone | 0d? | 2025-04-28 | 2025-04-28 | 1585, 1525FS+1d, 1589FS+1d, 1427 |  |  | 2025-04-28 | 2025-04-28 | 0d | 27d | 0d |  | SI Test | SIT | 129.71 | 6.15 | Green | Richard Puddephatt | GREEN | T2-TE-1000 |  | SITAG | T2 |
| 1429 | 1.4.1.4.7.3.3 | Regression Test Data Load Window |  | 14d | 2025-04-29 | 2025-05-16 | 1428 |  |  | 2025-04-28 | 2025-05-16 | 0d | 27d | 0d | start no earlier than 2025-04-28 | SI Test | SIT | 130.33 | 6.15 | Green | Richard Puddephatt | GREEN |  |  |  |  |
| 1430 | 1.4.1.4.8 | **Single Instance ADO** |  | 32d? | 2024-08-21 A | 2024-10-03 |  | 98% | 0.65d? | 2024-08-21 | 2024-10-03 | 0d | 32413d |  |  | SI Test | SIT | -701.67 | 6.1 | Overdue Start | Heath Thomas | RED |  |  |  |  |
| 1431 | 1.4.1.4.8.1 | **Single ADO Project for all Cohorts - Implementation and Test Phase** |  | 30d? | 2024-08-21 A | 2024-10-01 A |  | 100% |  | 2024-08-21 | 2024-10-01 | 0d |  |  |  | SI Test | SIT | -701.67 | 6.1 | Overdue Start | Heath Thomas | RED |  |  |  |  |
| 1432 | 1.4.1.4.8.1.1 | Create test plans and suites in master project |  | 2d? | 2024-08-21 A | 2024-08-22 A |  | 100% |  | 2024-08-21 | 2024-08-22 | 0d |  |  | finish no earlier than 2024-08-22 | SI Test | SIT |  | 6.1 | Complete | Heath Thomas | COMPLETE |  |  |  |  |
| 1433 | 1.4.1.4.8.1.2 | Create area paths / iterations |  | 2d? | 2024-08-21 A | 2024-08-22 A |  | 100% |  | 2024-08-21 | 2024-08-22 | 0d |  |  | finish no earlier than 2024-08-22 | SI Test | SIT |  | 6.1 | Complete | Heath Thomas | COMPLETE |  |  |  |  |
| 1434 | 1.4.1.4.8.1.3 | Create IAM roles |  | 2d? | 2024-08-21 A | 2024-08-22 A |  | 100% |  | 2024-08-21 | 2024-08-22 | 0d |  |  | finish no earlier than 2024-08-22 | SI Test | SIT |  | 6.1 | Complete | Heath Thomas | COMPLETE |  |  |  |  |
| 1435 | 1.4.1.4.8.1.4 | Add users to roles |  | 1d? | 2024-08-23 A | 2024-08-23 A |  | 100% |  | 2024-08-23 | 2024-08-23 | 0d |  |  | start no earlier than 2024-08-23 | SI Test | SIT |  | 6.1 | Complete | Heath Thomas | COMPLETE |  |  |  |  |
| 1436 | 1.4.1.4.8.1.5 | **Testing permissions** |  | 2d? | 2024-08-27 A | 2024-08-28 A |  | 100% |  | 2024-08-27 | 2024-08-28 | 0d |  |  |  | SI Test | SIT |  | 6.1 | Complete | Heath Thomas | COMPLETE |  |  |  |  |
| 1437 | 1.4.1.4.8.1.5.1 | Adding tests |  | 2d? | 2024-08-27 A | 2024-08-28 A |  | 100% |  | 2024-08-27 | 2024-08-28 | 0d |  |  | finish no earlier than 2024-08-28 | SI Test | SIT |  | 6.1 | Complete | Heath Thomas | COMPLETE |  |  |  |  |
| 1438 | 1.4.1.4.8.1.5.2 | Deleting tests |  | 2d? | 2024-08-27 A | 2024-08-28 A |  | 100% |  | 2024-08-27 | 2024-08-28 | 0d |  |  | finish no earlier than 2024-08-28 | SI Test | SIT |  | 6.1 | Complete | Heath Thomas | COMPLETE |  |  |  |  |
| 1439 | 1.4.1.4.8.1.5.3 | Adding tests to incorrect Cohort |  | 2d? | 2024-08-27 A | 2024-08-28 A |  | 100% |  | 2024-08-27 | 2024-08-28 | 0d |  |  | finish no earlier than 2024-08-28 | SI Test | SIT |  | 6.1 | Complete | Heath Thomas | COMPLETE |  |  |  |  |
| 1440 | 1.4.1.4.8.1.5.4 | Add / delete defects |  | 2d? | 2024-08-27 A | 2024-08-28 A |  | 100% |  | 2024-08-27 | 2024-08-28 | 0d |  |  | finish no earlier than 2024-08-28 | SI Test | SIT |  | 6.1 | Complete | Heath Thomas | COMPLETE |  |  |  |  |
| 1441 | 1.4.1.4.8.1.6 | Migrate defects from cohort project to master - Option 2 |  | 3d | 2024-09-23 A | 2024-09-25 A |  | 100% |  | 2024-09-23 | 2024-09-25 | 0d |  |  | start no earlier than 2024-09-23 | SI Test | SIT |  | 6.1 | Complete | Heath Thomas | COMPLETE |  |  |  |  |
| 1442 | 1.4.1.4.8.1.7 | Testing Permissions - Evidence attachment security |  | 10d? | 2024-09-18 A | 2024-10-01 A |  | 100% |  | 2024-09-18 | 2024-10-01 | 0d |  |  | finish no earlier than 2024-10-01 | SI Test | SIT |  | 6.1 | Complete | Heath Thomas | COMPLETE |  |  |  |  |

Notes:
- 1413: 18/12/24 - Programme walked through the proposed updates to Regression plan at Dec SITAG. Due to return to Jan SITAG to formally approve and rebaseline this date.
- 1414: 18/12/24 - Programme walked through the proposed updates to Regression plan at Dec SITAG. Due to return to Jan SITAG to formally approve and rebaseline this date.
- 1415: 18/12/24 - Programme walked through the proposed updates to Regression plan at Dec SITAG. Due to return to Jan SITAG to formally approve and rebaseline this date.
- 1416: 18/12/24 - Programme walked through the proposed updates to Regression plan at Dec SITAG. Due to return to Jan SITAG to formally approve and rebaseline this date.
- 1417: 18/12/24 - Programme walked through the proposed updates to Regression plan at Dec SITAG. Due to return to Jan SITAG to formally approve and rebaseline this date.
- 1418: 18/12/24 - Programme walked through the proposed updates to Regression plan at Dec SITAG. Due to return to Jan SITAG to formally approve and rebaseline this date.
- 1419: 18/12/24 - Programme walked through the proposed updates to Regression plan at Dec SITAG. Due to return to Jan SITAG to formally approve and rebaseline this date.
- 1420: 18/12/24 - Programme walked through the proposed updates to Regression plan at Dec SITAG. Due to return to Jan SITAG to formally approve and rebaseline this date.
- 1421: 18/12/24 - Programme walked through the proposed updates to Regression plan at Dec SITAG. Due to return to Jan SITAG to formally approve and rebaseline this date.
- 1422: 18/12/24 - Programme walked through the proposed updates to Regression plan at Dec SITAG. Due to return to Jan SITAG to formally approve and rebaseline this date.
- 1423: 18/12/24 - Programme walked through the proposed updates to Regression plan at Dec SITAG. Due to return to Jan SITAG to formally approve and rebaseline this date.
- 1424: 18/12/24 - Programme walked through the proposed updates to Regression plan at Dec SITAG. Due to return to Jan SITAG to formally approve and rebaseline this date.
- 1425: 18/12/24 - Programme walked through the proposed updates to Regression plan at Dec SITAG. Due to return to Jan SITAG to formally approve and rebaseline this date.

| ID | WBS | Task | Duration | Start | Finish | Complete | Remaining | Baseline start | Baseline finish | Baseline duration | Total slack | Constraint | Responsible | Text9 | Task Status | Update Version | Sched Status | MHHS Resource Name | RAG |
| --- | --- | --- | --- | --- | --- | --- | --- | --- | --- | --- | --- | --- | --- | --- | --- | --- | --- | --- | --- |
| 1443 | 1.4.1.4.8.2 | **ADO Dashboard Updates** | 20d? | 2024-09-03 A | 2024-09-30 A | 100% |  | 2024-09-03 | 2024-09-30 | 0d |  |  | SI Test | SIT | -701.67 | 6.1 | Overdue Start | Heath Thomas |  |
| 1444 | 1.4.1.4.8.2.1 | Update reporting dashboards in ADO | 3d | 2024-09-03 A | 2024-09-05 A | 100% |  | 2024-09-03 | 2024-09-05 | 0d |  | start no earlier than 2024-09-03 | SI Test | SIT |  | 6.1 | Complete | Heath Thomas | COMPLETE |
| 1445 | 1.4.1.4.8.2.2 | Review dashboards with SI LDP leads | 16d | 2024-09-06 A | 2024-09-27 A | 100% |  | 2024-09-06 | 2024-09-27 | 0d |  | start no earlier than 2024-09-06 | SI Test | SIT |  | 6.1 | Complete | Heath Thomas | COMPLETE |
| 1446 | 1.4.1.4.8.2.3 | Review dashboards with SRO | 16d | 2024-09-09 A | 2024-09-30 A | 100% |  | 2024-09-09 | 2024-09-30 | 0d |  | start no earlier than 2024-09-09 | SI Test | SIT |  | 6.1 | Complete | Heath Thomas | COMPLETE |
| 1447 | 1.4.1.4.8.2.4 | Update dashboards following review | 2d | 2024-09-12 A | 2024-09-13 A | 100% |  | 2024-09-12 | 2024-09-13 | 0d |  | start no earlier than 2024-09-12 | SI Test | SIT |  | 6.1 | Complete | Heath Thomas | COMPLETE |
| 1448 | 1.4.1.4.8.2.5 | Document changes to dashboard creation process | 4d | 2024-09-16 A | 2024-09-19 A | 100% |  | 2024-09-16 | 2024-09-19 | 0d |  | start no earlier than 2024-09-16 | SI Test | SIT |  | 6.1 | Complete | Heath Thomas | COMPLETE |
| 1449 | 1.4.1.4.8.2.6 | Update SIT Dashboards for Sprints 4.1 & 4.2 across all Cohorts | 1d? | 2024-09-03 A | 2024-09-03 A | 100% |  | 2024-09-03 | 2024-09-03 | 0d |  | start no earlier than 2024-09-03 | SI Test | SIT |  | 6.1 | Complete | Heath Thomas | COMPLETE |
| 1450 | 1.4.1.4.8.3 | **Reporting Changes - PowerBI & QIP** | 23d? | 2024-08-23 A | 2024-09-24 | 70% | 6.9d? | 2024-08-23 | 2024-09-24 | 0d | 32420d |  | SI Test | SIT | -701.67 | 6.1 | Overdue Start | Heath Thomas |  |
| 1451 | 1.4.1.4.8.3.1 | Design, Create and ETL ADO Entities into PowerBI Data Model | 1d? | 2024-08-23 A | 2024-08-23 A | 100% |  | 2024-08-23 | 2024-08-23 | 0d |  | start no earlier than 2024-08-23 | SI Test | SIT |  | 6.1 | Complete | Heath Thomas | COMPLETE |
| 1452 | 1.4.1.4.8.3.2 | Determine Relationships between ADO Entities & Attributes | 1d? | 2024-08-27 A | 2024-08-27 A | 100% |  | 2024-08-27 | 2024-08-27 | 0d |  | start no earlier than 2024-08-27 | SI Test | SIT |  | 6.1 | Complete | Heath Thomas | COMPLETE |
| 1453 | 1.4.1.4.8.3.3 | Create Relevant Dax Measures | 1d? | 2024-08-28 A | 2024-08-28 A | 100% |  | 2024-08-28 | 2024-08-28 | 0d |  | start no earlier than 2024-08-28 | SI Test | SIT |  | 6.1 | Complete | Heath Thomas | COMPLETE |
| 1454 | 1.4.1.4.8.3.4 | Design & Build Visualisations (Graphs) | 1d? | 2024-08-29 A | 2024-08-29 A | 100% |  | 2024-08-29 | 2024-08-29 | 0d |  | start no earlier than 2024-08-29 | SI Test | SIT |  | 6.1 | Complete | Heath Thomas | COMPLETE |
| 1455 | 1.4.1.4.8.3.5 | Implement Filters | 1d? | 2024-09-23 A | 2024-09-23 A | 100% |  | 2024-09-23 | 2024-09-23 | 0d |  | start no earlier than 2024-09-23 | SI Test | SIT |  | 6.1 | Complete | Heath Thomas | COMPLETE |
| 1456 | 1.4.1.4.8.3.6 | Check Data Quality & Integrity | 1d? | 2024-09-24 A | 2024-09-24 A | 100% |  | 2024-09-24 | 2024-09-24 | 0d |  | start no earlier than 2024-09-24 | SI Test | SIT |  | 6.1 | Complete | Heath Thomas | COMPLETE |
| 1457 | 1.4.1.4.8.3.7 | Performance Optimisation | 1d? | 2024-09-24 A | 2024-09-24 A | 100% |  | 2024-09-24 | 2024-09-24 | 0d |  | start no earlier than 2024-09-24 | SI Test | SIT |  | 6.1 | Complete | Heath Thomas | COMPLETE |
| 1458 | 1.4.1.4.8.3.8 | Publish (QIP) | 1d? | 2024-09-04 | 2024-09-04 |  |  | 2024-09-04 | 2024-09-04 | 0d | 32434d | start no earlier than 2024-09-04 | SI Test | SIT | -106.67 | 6.1 | Overdue Start | Heath Thomas | RED |
| 1459 | 1.4.1.4.8.3.9 | Review & UAT | 1d? | 2024-09-05 | 2024-09-05 |  |  | 2024-09-05 | 2024-09-05 | 0d | 32433d | start no earlier than 2024-09-05 | SI Test | SIT | -105.67 | 6.1 | Overdue Start | Heath Thomas | RED |
| 1460 | 1.4.1.4.8.3.10 | QIP Training Material & User Guides | 1d? | 2024-09-10 | 2024-09-10 |  |  | 2024-09-10 | 2024-09-10 | 0d | 32430d | start no earlier than 2024-09-10 | SI Test | SIT | -100.67 | 6.1 | Overdue Start | Heath Thomas | RED |
| 1461 | 1.4.1.4.8.4 | **Reporting Changes - Daily Excel Extract & PDF** | 2d | 2024-09-05 A | 2024-09-06 A | 100% |  | 2024-09-05 | 2024-09-06 | 0d |  |  | SI Test | SIT | -701.67 | 6.1 | Overdue Start | Heath Thomas | RED |
| 1462 | 1.4.1.4.8.4.1 | Excel Daily Report changes (Refer to above) | 2d | 2024-09-05 A | 2024-09-06 A | 100% |  | 2024-09-05 | 2024-09-06 | 0d |  | start no earlier than 2024-09-05 | SI Test | SIT |  | 6.1 | Complete | Heath Thomas | COMPLETE |
| 1463 | 1.4.1.4.8.4.2 | PDF Daily Report changes (Refer to Above) | 2d | 2024-09-05 A | 2024-09-06 A | 100% |  | 2024-09-05 | 2024-09-06 | 0d |  | start no earlier than 2024-09-05 | SI Test | SIT |  | 6.1 | Complete | Heath Thomas | COMPLETE |
| 1464 | 1.4.1.4.8.5 | **Documentation Updates** | 23d? | 2024-09-02 A | 2024-10-02 A | 100% |  | 2024-09-02 | 2024-10-02 | 0d |  |  | SI Test | SIT | -701.67 | 6.1 | Overdue Start | Heath Thomas |  |
| 1465 | 1.4.1.4.8.5.1 | Changes to onboarding process (security) | 10d | 2024-09-02 A | 2024-09-13 A | 100% |  | 2024-09-02 | 2024-09-13 | 0d |  | start no earlier than 2024-09-02 | SI Test | SIT |  | 6.1 | Complete | Heath Thomas | COMPLETE |
| 1466 | 1.4.1.4.8.5.2 | Update the documents on loading tests into ADO? | 10d | 2024-09-02 A | 2024-09-13 A | 100% |  | 2024-09-02 | 2024-09-13 | 0d |  | start no earlier than 2024-09-02 | SI Test | SIT |  | 6.1 | Complete | Heath Thomas | COMPLETE |
| 1467 | 1.4.1.4.8.5.3 | Update ADO Training material | 10d | 2024-09-02 A | 2024-09-13 A | 100% |  | 2024-09-02 | 2024-09-13 | 0d |  | start no earlier than 2024-09-02 | SI Test | SIT |  | 6.1 | Complete | Heath Thomas | COMPLETE |
| 1468 | 1.4.1.4.8.5.4 | Update ADO User Guide | 10d | 2024-09-02 A | 2024-09-13 A | 100% |  | 2024-09-02 | 2024-09-13 | 0d |  | start no earlier than 2024-09-02 | SI Test | SIT |  | 6.1 | Complete | Heath Thomas | COMPLETE |
| 1469 | 1.4.1.4.8.5.5 | Update ADO Configuration document | 10d | 2024-09-02 A | 2024-09-13 A | 100% |  | 2024-09-02 | 2024-09-13 | 0d |  | start no earlier than 2024-09-02 | SI Test | SIT |  | 6.1 | Complete | Heath Thomas | COMPLETE |
| 1470 | 1.4.1.4.8.5.6 | Update ADO Training Material and User Guide following SRO review | 1d? | 2024-10-02 A | 2024-10-02 A | 100% |  | 2024-10-02 | 2024-10-02 | 0d |  | start no earlier than 2024-10-02 | SI Test | SIT |  | 6.1 | Complete | Heath Thomas | COMPLETE |

Notes:
- 1458: 13/11/24 - This is on hold, assessed whether this is needed and if deemed so, will be resumed.
- 1459: 13/11/24 - This is on hold, assessed whether this is needed and if deemed so, will be resumed.
- 1460: 13/11/24 - This is on hold, assessed whether this is needed and if deemed so, will be resumed.

| ID | WBS | Task | Type | Duration | Start | Finish | Predecessors | Complete | Remaining | Baseline start | Baseline finish | Baseline duration | Baseline 1 start | Baseline 1 finish | Total slack | Constraint | Baseline cost | Responsible | Text9 | Task Status | Update Version | Sched Status | MHHS Resource Name | RAG | Involved | MHHS Programme Phase | Text29 | Artefact ID | Milestone ID | Tier | Future RAG |
| --- | --- | --- | --- | --- | --- | --- | --- | --- | --- | --- | --- | --- | --- | --- | --- | --- | --- | --- | --- | --- | --- | --- | --- | --- | --- | --- | --- | --- | --- | --- | --- |
| 1471 | 1.4.1.4.8.6 | **ADO Changes - Review Stage** |  | 19d? | 2024-09-09 A | 2024-10-03 A |  | 100% |  | 2024-09-09 | 2024-10-03 | 0d |  |  |  |  |  | SI Test | SIT | -701.67 | 6.1 | Overdue Start | Heath Thomas |  |  |  |  |  |  |  |  |
| 1472 | 1.4.1.4.8.6.1 | Review implementation with SI LDP leads |  | 1d? | 2024-09-27 A | 2024-09-27 A |  | 100% |  | 2024-09-27 | 2024-09-27 | 0d |  |  |  | start no earlier than 2024-09-27 |  | SI Test | SIT |  | 6.1 | Complete | Heath Thomas | COMPLETE |  |  |  |  |  |  |  |
| 1473 | 1.4.1.4.8.6.2 | Review implementation with SRO |  | 1d? | 2024-09-30 A | 2024-09-30 A |  | 100% |  | 2024-09-30 | 2024-09-30 | 0d |  |  |  | start no earlier than 2024-09-30 |  | SI Test | SIT |  | 6.1 | Complete | Heath Thomas | COMPLETE |  |  |  |  |  |  |  |
| 1474 | 1.4.1.4.8.6.3 | LDP Review - ADO User Guide, Training Materials |  | 5d | 2024-09-09 A | 2024-09-13 A |  | 100% |  | 2024-09-09 | 2024-09-13 | 0d |  |  |  | start no earlier than 2024-09-09 |  | SI Test | SIT |  | 6.1 | Complete | Heath Thomas | COMPLETE |  |  |  |  |  |  |  |
| 1475 | 1.4.1.4.8.6.4 | SRO Review - ADO User Guide, Training Materials |  | 1d? | 2024-09-30 A | 2024-09-30 A |  | 100% |  | 2024-09-30 | 2024-09-30 | 0d |  |  |  | start no earlier than 2024-09-30 |  | SI Test | SIT |  | 6.1 | Complete | Heath Thomas | COMPLETE |  |  |  |  |  |  |  |
| 1476 | 1.4.1.4.8.6.5 | LDP Review - Config doc |  | 1d? | 2024-09-30 A | 2024-09-30 A |  | 100% |  | 2024-09-30 | 2024-09-30 | 0d |  |  |  | start no earlier than 2024-09-30 |  | SI Test | SIT |  | 6.1 | Complete | Heath Thomas | COMPLETE |  |  |  |  |  |  |  |
| 1477 | 1.4.1.4.8.6.6 | SRO Review - Config doc |  | 1d? | 2024-09-30 A | 2024-09-30 A |  | 100% |  | 2024-09-30 | 2024-09-30 | 0d |  |  |  | start no earlier than 2024-09-30 |  | SI Test | SIT |  | 6.1 | Complete | Heath Thomas | COMPLETE |  |  |  |  |  |  |  |
| 1478 | 1.4.1.4.8.6.7 | SRO Sign-off of all changes |  | 1d? | 2024-10-03 A | 2024-10-03 A |  | 100% |  | 2024-10-03 | 2024-10-03 | 0d |  |  |  | start no earlier than 2024-10-03 |  | SI Test | SIT |  | 6.1 | Complete | Heath Thomas | COMPLETE |  |  |  |  |  |  |  |
| 1479 | 1.4.1.4.8.7 | **Azure DevOps Changes - Final Implementation** |  | 1d? | 2024-10-03 A | 2024-10-03 A |  | 100% |  | 2024-10-03 | 2024-10-03 | 0d |  |  |  |  |  | SI Test | SIT | -701.67 | 6.1 | Overdue Start | Heath Thomas |  |  |  |  |  |  |  |  |
| 1480 | 1.4.1.4.8.7.1 | Final task rollout |  | 1d? | 2024-10-03 A | 2024-10-03 A |  | 100% |  | 2024-10-03 | 2024-10-03 | 0d |  |  |  | start no earlier than 2024-10-03 |  | SI Test | SIT |  | 6.1 | Complete | Heath Thomas | COMPLETE |  |  |  |  |  |  |  |
| 1481 | 1.4.1.4.8.7.2 | ADO Training Drop-in Session ahead of Cycle 3 |  | 1d? | 2024-10-03 A | 2024-10-03 A |  | 100% |  | 2024-10-03 | 2024-10-03 | 0d |  |  |  | start no earlier than 2024-10-03 |  | SI Test | SIT |  | 6.1 | Complete | Heath Thomas | COMPLETE |  |  |  |  |  |  |  |
| 1482 | 1.4.2 | **SIT Execution** |  | 32917d? | 2022-10-31 A | 2148-12-31 |  | 18% | 27090.1d? | 2022-10-31 | 2025-11-27 | 390d | 2023-10-30 | 2025-04-25 | 0d |  | -0 | N/A | SIT |  | 5.0 |  | N/A |  | N/A | Systems Integration Testing (SIT) | SITAG |  |  |  |  |
| 1483 | 1.4.2.1 | System Integration Testing Start (M9) | milestone | 0d | 2023-10-30 A | 2023-10-30 A | 680FS+5d, 594 | 100% |  | 2023-10-30 | 2023-10-30 | 0d | 2023-10-30 | 2023-10-30 |  | must start on 2023-10-30 |  | CPT | SIT |  | 5.11 | Complete |  | COMPLETE | PMO | Systems Integration Testing (SIT) | PSG | MHHS-ART071 | T1-TE-1000 | T1 |  |
| 1484 | 1.4.2.2 | **SIT Component Integration Testing** |  | 32657d | 2023-10-30 A | 2148-12-31 |  | 8% | 30100.6d | 2023-10-30 | 2024-03-11 | 95d | 2023-10-30 | 2024-03-08 | 0d |  |  | N/A | SIT |  | 5.0 |  | N/A |  | N/A | Systems Integration Testing (SIT) | SITAG |  |  |  | D24A - Industry Integration Test Completion Report |
| 1485 | 1.4.2.2.1 | SIT Component Integration Testing Start | milestone | 0d | 2023-10-30 A | 2023-10-30 A | 1483 | 100% |  | 2023-10-30 | 2023-10-30 | 0d | 2023-10-30 | 2023-10-30 |  |  |  | SI Test | SIT |  | 5.11 | Complete |  | COMPLETE | PP | Systems Integration Testing (SIT) |  |  |  |  |  |
| 1486 | 1.4.2.2.2 | Component Integration Testing Interval 1 Start | milestone | 0d | 2023-10-30 A | 2023-10-30 A | 680SS+1d, 601, 605, 609, 114 | 100% |  | 2023-10-30 | 2023-10-30 | 0d | 2023-10-30 | 2023-10-30 |  |  |  | SI Test | SIT |  | 5.11 | Complete |  | COMPLETE | PP | Systems Integration Testing (SIT) | SITAG | MHHS-ART071 | T3-TE-0060 | T3 |  |
| 1487 | 1.4.2.2.3 | Component Integration Testing Interval 2 Start | milestone | 0d | 2023-11-13 A | 2023-11-13 A | 707SS+5d, 601, 609, 605, 114 | 100% |  | 2023-11-13 | 2023-11-13 | 0d | 2023-11-13 | 2023-11-13 |  |  |  | SI Test | SIT |  | 5.12 | Complete |  | COMPLETE | PP | Systems Integration Testing (SIT) | SITAG |  | T3-TE-0061 | T3 |  |
| 1488 | 1.4.2.2.4 | Component Integration Testing Interval 3 Start | milestone | 0d | 2023-11-27 A | 2023-11-27 A | 739SS+5d, 601, 605, 609, 114 | 100% |  | 2023-11-27 | 2023-11-27 | 0d | 2023-11-27 | 2023-11-27 |  |  |  | SI Test | SIT |  | 5.0 | Complete |  | COMPLETE | PP | Systems Integration Testing (SIT) | SITAG |  | T3-TE-0062 | T3 |  |
| 1489 | 1.4.2.2.5 | Component Integration Testing Interval 4 Start | milestone | 0d | 2023-12-11 A | 2023-12-11 A | 771SS+5d, 601, 605, 609, 114 | 100% |  | 2023-12-11 | 2023-12-11 | 0d | 2023-12-11 | 2023-12-11 |  |  |  | SI Test | SIT |  | 5.0 | Complete |  | COMPLETE | PP | Systems Integration Testing (SIT) | SITAG |  | T3-TE-0063 | T3 |  |
| 1490 | 1.4.2.2.6 | Component Integration Testing Interval 5 Start | milestone | 0d | 2024-01-15 A | 2024-01-15 A | 803SS+5d, 601, 605, 609, 114 | 100% |  | 2024-01-15 | 2024-01-15 | 0d | 2024-01-15 | 2024-01-15 |  |  |  | SI Test | SIT |  | 5.0 | Complete |  | COMPLETE | PP | Systems Integration Testing (SIT) | SITAG |  | T3-TE-0064 | T3 |  |
| 1491 | 1.4.2.2.7 | Component Integration Testing Interval 6 Start | milestone | 0d | 2024-01-29 A | 2024-01-29 A | 601, 605, 609, 835, 114, 647 | 100% |  | 2024-01-29 | 2024-01-29 | 0d | 2024-01-29 | 2024-01-29 |  | must start on 2024-01-29 |  | SI Test | SIT |  | 5.0 | Complete |  | COMPLETE | PP | Systems Integration Testing (SIT) | SITAG |  | T3-TE-0065 | T3 |  |
| 1492 | 1.4.2.2.8 | SIT Component Integration Testing Execution |  | 85d | 2023-10-30 A | 2024-02-23 A | 1486SS | 100% |  | 2023-10-30 | 2024-02-23 | 85d | 2023-10-30 | 2024-02-23 |  | must start on 2023-10-30 |  | SI Test | SIT |  | 5.0 | Complete |  | COMPLETE | PP | Systems Integration Testing (SIT) |  |  |  |  | D24A - Industry Integration Test Completion Report |
| 1493 | 1.4.2.2.9 | SIT Component Integration Testing End (incl. confirmation that PPs have submitted their Test Completion Reports to Programme for assurance) |  | 1566d | 2024-02-23 A | 2148-12-31 | 1492FF |  | 1566d | 2024-02-23 | 2024-02-23 | 0d | 2024-02-23 | 2024-02-23 | 0d |  |  | SI Test | SIT | -300.29 | 5.19 | Overdue Start |  | RED | PP | Systems Integration Testing (SIT) | SITAG | MHHS-ART074 | T3-TE-0032 | T3 |  |
| 1494 | 1.4.2.2.10 | Assurance of PPs Test Completion Reports |  | 30d | 2024-01-22 A | 2024-03-01 A | 1493FF+5d | 100% |  | 2024-01-22 | 2024-03-01 | 30d | 2024-01-22 | 2024-03-01 |  |  |  | SI Test | SIT |  | 5.19 | Complete |  | COMPLETE | PP | Systems Integration Testing (SIT) |  |  |  |  |  |

| ID | WBS | Task | Type | Duration | Start | Finish | Predecessors | Complete | Remaining | Baseline start | Baseline finish | Baseline duration | Baseline 1 start | Baseline 1 finish | Total slack | Free slack | Baseline cost | Responsible | Involved | Text9 | Update Version | MHHS Resource Name | MHHS Programme Phase | Sched Status | RAG | Artefact ID | Milestone ID | Text29 | Tier | Future RAG | Task Status |
| --- | --- | --- | --- | --- | --- | --- | --- | --- | --- | --- | --- | --- | --- | --- | --- | --- | --- | --- | --- | --- | --- | --- | --- | --- | --- | --- | --- | --- | --- | --- | --- |
| 1495 | 1.4.2.2.11 | **SIT CI Test Completion Report** |  | 18d | 2024-02-07 A | 2024-03-01 A |  | 100% |  | 2024-02-07 | 2024-03-01 | 18d | 2024-02-07 | 2024-03-01 |  |  |  | N/A | N/A | SIT | 5.0 | N/A | Systems Integration Testing (SIT) |  |  |  |  |  |  |  |  |
| 1496 | 1.4.2.2.11.1 | Develop document |  | 13d | 2024-02-07 A | 2024-02-23 A | 1493FF | 100% |  | 2024-02-07 | 2024-02-23 | 13d | 2024-02-07 | 2024-02-23 |  |  |  | SI Test |  | SIT | 5.19 |  | Systems Integration Testing (SIT) | Complete | COMPLETE |  |  |  |  |  |  |
| 1497 | 1.4.2.2.11.2 | Review & agree document |  | 5d | 2024-02-26 A | 2024-03-01 A | 1496, 1494FF | 100% |  | 2024-02-26 | 2024-03-01 | 5d | 2024-02-26 | 2024-03-01 |  |  |  | SI Test | PP,IPA | SIT | 5.19 |  | Systems Integration Testing (SIT) | Complete | COMPLETE |  |  |  |  |  |  |
| 1498 | 1.4.2.2.12 | SIT Component Integration Testing Test Completion Report Approved | milestone | 0d | 2024-03-11 A | 2024-03-11 A | 1497FS+6d | 100% |  | 2024-03-11 | 2024-03-11 | 0d | 2024-03-08 | 2024-03-08 |  |  |  | SI Test | PP | SIT | 5.18 |  | Systems Integration Testing (SIT) | Complete | COMPLETE | MHHS-ART074 | T2-TE-0600 | SITAG | T2 |  |  |
| 1499 | 1.4.2.3 | **SIT - Minimum Viable Cohort (MVC)** |  | 735d? | 2022-10-31 A | 2025-08-22 |  | 31% | 504.98d? | 2022-10-31 | 2025-08-22 | 240d | 2024-03-11 | 2025-02-07 | 32182d |  | -0 | N/A | N/A | SIT | 5.0 | N/A | Systems Integration Testing (SIT) |  |  |  |  | SITAG |  |  |  |
| 1500 | 1.4.2.3.1 | **SIT Functional Testing (MVC)** |  | 730d? | 2022-10-31 A | 2025-08-15 |  | 44% | 412.18d? | 2022-10-31 | 2025-08-15 | 225d | 2024-03-11 | 2025-01-17 | 32187d |  |  | N/A | N/A | SIT | 5.0 | N/A | Systems Integration Testing (SIT) |  |  |  |  |  |  |  |  |
| 1501 | 1.4.2.3.1.1 | SIT Functional Testing Start | milestone | 0d | 2024-03-11 A | 2024-03-11 A | 1498, 965FS+5d, 842, 850, 851, 852, 859 | 100% |  | 2024-03-11 | 2024-03-11 | 0d | 2024-03-11 | 2024-03-11 |  |  |  | SI Test | PP | SIT | 6.1 |  | Systems Integration Testing (SIT) | Complete | COMPLETE | MHHS-ART073 | T3-TE-0034 | SITAG | T3 |  |  |
| 1502 | 1.4.2.3.1.2 | **SIT Functional Testing Execution (Minimum Viable Cohort)** |  | 730d? | 2022-10-31 A | 2025-08-15 |  | 44% | 412.18d? | 2022-10-31 | 2025-08-15 | 225d | 2024-03-11 | 2025-01-17 | 32187d |  |  | N/A | N/A | SIT | 5.0 | N/A | Systems Integration Testing (SIT) |  |  |  |  |  |  | D24C - E2E Test Completion Report | M10 |
| 1503 | 1.4.2.3.1.2.1 | **Cycle 1 (Full Cycle)** |  | 70d | 2024-03-11 A | 2024-06-14 A |  | 100% |  | 2024-03-11 | 2024-06-14 | 90d | 2024-03-11 | 2024-07-12 |  |  |  | N/A | N/A | SIT | 5.0 | N/A | Systems Integration Testing (SIT) |  |  |  |  |  |  |  |  |
| 1504 | 1.4.2.3.1.2.1.1 | Test Execution |  | 55d | 2024-03-11 A | 2024-05-24 A | 1501SS-1d, 929 | 100% |  | 2024-03-11 | 2024-05-24 | 80d | 2024-03-11 | 2024-06-28 |  |  |  | PP | SI Test | SIT | 5.0 |  | Systems Integration Testing (SIT) | Complete | COMPLETE |  |  |  |  |  |  |
| 1505 | 1.4.2.3.1.2.1.2 | Defect resolution, assurance, review, data & environments maintenance |  | 15d | 2024-05-27 A | 2024-06-14 A | 1504 | 100% |  | 2024-05-27 | 2024-06-14 | 10d | 2024-07-01 | 2024-07-12 |  |  |  | SI Test | PP | SIT | 5.0 |  | Systems Integration Testing (SIT) | Complete | COMPLETE |  |  |  |  |  |  |
| 1506 | 1.4.2.3.1.2.2 | **Cycle 2 (Defect retests and targeted regression testing)** |  | 80d | 2024-06-17 A | 2024-10-04 A |  | 100% |  | 2024-06-17 | 2024-10-04 | 50d | 2024-07-15 | 2024-09-20 |  |  |  | N/A | N/A | SIT | 5.0 | N/A | Systems Integration Testing (SIT) |  |  |  |  |  |  |  |  |
| 1507 | 1.4.2.3.1.2.2.1 | Test Execution |  | 70d | 2024-06-17 A | 2024-09-20 A | 1505, 934 | 100% |  | 2024-06-17 | 2024-09-20 | 40d | 2024-07-15 | 2024-09-06 |  |  |  | PP | SI Test | SIT | 5.0 | Roger Robar | Systems Integration Testing (SIT) | Complete | COMPLETE |  |  |  |  |  |  |
| 1508 | 1.4.2.3.1.2.2.2 | Defect resolution, assurance, review, data & environments maintenance |  | 10d | 2024-09-23 A | 2024-10-04 A | 1507 | 100% |  | 2024-09-23 | 2024-10-04 | 10d | 2024-09-09 | 2024-09-20 |  |  |  | SI Test | PP | SIT | 5.0 | Roger Robar | Systems Integration Testing (SIT) | Complete | COMPLETE |  |  |  |  |  |  |
| 1509 | 1.4.2.3.1.2.3 | **SIT Functional Testing back-up progress risk-assessment** |  | 0d | 2022-10-31 | 2022-10-31 |  |  |  | 2022-10-31 | 2022-10-31 | 20d | 2024-09-23 | 2024-10-18 | 32917d |  |  | N/A | N/A | SIT | 5.31 | N/A | Systems Integration Testing (SIT) |  |  |  |  |  |  |  |  |
| 1510 | 1.4.2.3.1.2.3.1 | Back-up risk-assessment of SIT Functional progress to assess whether Qualification Execution can start early | inactive | 15d | 2024-10-07 | 2024-10-25 | 1508 |  |  | 2024-10-07 | 2024-10-25 | 15d | 2024-09-23 | 2024-10-11 | 32392d | 0d |  | SI Test | Code Bodies,PP,IPA | SIT | 5.31 | Nicola Farley | Systems Integration Testing (SIT) |  | GREEN |  |  |  |  |  | -73.67 |
| 1511 | 1.4.2.3.1.2.3.2 | Back-up SITAG decision on early Qualification Testing Execution start | milestone, inactive | 0d | 2024-11-01 | 2024-11-01 | 1510FS+5d |  |  | 2024-11-01 | 2024-11-01 | 0d | 2024-10-18 | 2024-10-18 | 32392d |  |  | SI Test | Code Bodies,PP,IPA | SIT | 5.31 | Nicola Farley | Systems Integration Testing (SIT) |  | GREEN |  |  | QAG | T3 |  | -48.29 |
| 1512 | 1.4.2.3.1.2.4 | **Cycle 3 (Defect retests and targeted regression testing)** |  | 105d? | 2024-10-21 A | 2025-03-14 |  | 28% | 76.05d? | 2024-10-21 | 2025-03-14 | 30d | 2024-09-23 | 2024-11-01 |  |  |  | SI Test | N/A | SIT | 5.0 | N/A | Systems Integration Testing (SIT) |  |  |  |  |  |  |  |  |
| 1513 | 1.4.2.3.1.2.4.1 | Sprint 5 |  | 10d? | 2024-10-21 A | 2024-11-01 A | 140SS-1d | 100% |  | 2024-10-21 | 2024-11-01 | 0d |  |  |  |  |  | SI Test |  | SIT | 6.0 | Roger Robar |  | Complete | COMPLETE |  |  |  |  |  |  |
| 1514 | 1.4.2.3.1.2.4.2 | Sprint 6 |  | 10d? | 2024-11-04 A | 2024-11-15 A | 1513 | 100% |  | 2024-11-04 | 2024-11-15 | 0d |  |  |  |  |  | SI Test |  | SIT | 6.0 | Roger Robar |  | Complete | COMPLETE |  |  |  |  |  |  |
| 1515 | 1.4.2.3.1.2.4.3 | Sprint 7 |  | 10d? | 2024-11-18 A | 2024-11-29 A | 1514 | 100% |  | 2024-11-18 | 2024-11-29 | 0d |  |  |  |  |  | SI Test |  | SIT | 6.0 | Roger Robar |  | Complete | COMPLETE |  |  |  |  |  |  |
| 1516 | 1.4.2.3.1.2.4.4 | Sprint 8 |  | 15d? | 2024-12-02 A | 2024-12-20 | 1515 | 50% | 7.5d? | 2024-12-02 | 2024-12-20 | 0d |  |  | 27d | 0d |  | SI Test |  | SIT | 6.0 | Roger Robar |  | Green | GREEN |  |  |  |  |  |  |
| 1517 | 1.4.2.3.1.2.4.5 | Christmas downtime |  | 10d? | 2024-12-23 | 2025-01-03 | 1516 |  |  | 2024-12-23 | 2025-01-03 | 0d |  |  | 27d | 0d |  | SI Test |  | SIT | 6.0 | Roger Robar |  | Green | GREEN |  |  |  |  |  | 3.33 |
| 1518 | 1.4.2.3.1.2.4.6 | Sprint 9 |  | 10d? | 2025-01-06 | 2025-01-17 | 1517 |  |  | 2025-01-06 | 2025-01-17 | 0d |  |  | 27d | 0d |  | SI Test |  | SIT | 6.0 | Roger Robar |  | Green | GREEN |  |  |  |  |  | 17.33 |
| 1519 | 1.4.2.3.1.2.4.7 | Sprint 10 |  | 10d? | 2025-01-20 | 2025-01-31 | 1518 |  |  | 2025-01-20 | 2025-01-31 | 0d |  |  | 27d | 0d |  | SI Test |  | SIT | 6.0 | Roger Robar |  | Green | GREEN |  |  |  |  |  | 31.33 |
| 1520 | 1.4.2.3.1.2.4.8 | Sprint 11 |  | 10d? | 2025-02-03 | 2025-02-14 | 1519 |  |  | 2025-02-03 | 2025-02-14 | 0d |  |  | 27d | 0d |  | SI Test |  | SIT | 6.0 | Roger Robar |  | Green | GREEN |  |  |  |  |  | 45.33 |
| 1521 | 1.4.2.3.1.2.4.9 | Sprint 12 |  | 10d? | 2025-02-17 | 2025-02-28 | 1520 |  |  | 2025-02-17 | 2025-02-28 | 0d |  |  | 27d | 0d |  | SI Test |  | SIT | 6.0 | Roger Robar |  | Green | GREEN |  |  |  |  |  | 59.33 |
| 1522 | 1.4.2.3.1.2.4.10 | Sprint 13 (RTTM Gap Analysis + CR056) |  | 10d? | 2025-03-03 | 2025-03-14 | 1521 |  |  | 2025-03-03 | 2025-03-14 | 0d |  |  | 27d | 0d |  | SI Test |  | SIT | 6.0 | Roger Robar |  | Green | GREEN |  |  |  |  |  | 73.33 |
| 1523 | 1.4.2.3.1.2.4.11 | Sprint 14 (RTTM Gap Analysis + CR056) |  | 10d? | 2025-03-17 | 2025-03-28 | 1522 |  |  | 2025-03-17 | 2025-03-28 | 0d |  |  | 27d | 0d |  | SI Test |  | SIT | 6.1 | Roger Robar |  | Green | GREEN |  |  |  |  |  | 87.33 |
| 1524 | 1.4.2.3.1.2.4.12 | Sprint 15 (Contingency 1) |  | 10d? | 2025-03-31 | 2025-04-11 | 1523 |  |  | 2025-03-31 | 2025-04-11 | 0d |  |  | 27d | 0d |  | SI Test |  | SIT | 6.1 | Roger Robar |  | Green | GREEN |  |  |  |  |  | 101.33 |
| 1525 | 1.4.2.3.1.2.4.13 | Sprint 16 (Contingency 2) |  | 10d? | 2025-04-14 | 2025-04-25 | 1524 |  |  | 2025-04-14 | 2025-04-25 | 0d |  |  | 27d | 0d |  | SI Test |  | SIT | 6.1 | Roger Robar |  | Green | GREEN |  |  |  |  |  | 115.33 |
| 1526 | 1.4.2.3.1.2.4.14 | SIT Functional Cycle 3 Complete |  | 1d? | 2025-04-28 | 2025-04-28 | 1525 |  |  |  |  |  |  |  | 32266d |  |  | SI Test |  | SIT | 6.13 | Roger Robar |  | No BL | GREEN |  | T2-TE-1150 |  | T2 |  | 129.33 |

Notes:
- 1510: Action: 5/12 - LC said change name from his to nicola and check dates based on new start date for non sit ldso testing
- 1511: Guidance: 13/8/24: To be removed because SIT has not made sufficient progress to allow early quaifation test start. 22/8/24: Approved at QAG on 22/8/24 to be removed

| ID | WBS | Task | Type | Duration | Start | Finish | Predecessors | Complete | Remaining | Actual start | Baseline start | Baseline finish | Baseline duration | Baseline 1 start | Baseline 1 finish | Total slack | Free slack | Constraint | Responsible | Text9 | Task Status | Update Version | Sched Status | MHHS Resource Name | RAG | Milestone ID | Text29 | Tier | Involved | MHHS Programme Phase | Artefact ID |
| --- | --- | --- | --- | --- | --- | --- | --- | --- | --- | --- | --- | --- | --- | --- | --- | --- | --- | --- | --- | --- | --- | --- | --- | --- | --- | --- | --- | --- | --- | --- | --- |
| 1527 | 1.4.2.3.1.2.5 | **SIT Functional Settlement Testing** |  | 230d? | 2024-06-17 | 2025-05-02 |  | 30% | 161.62d? | 2024-10-07 | 2024-06-17 | 2025-05-02 | 0d |  |  |  |  |  | SI Test | SIT | -685.67 | 6.12 | Overdue Start | Stuart Scott | RED |  |  |  |  |  |  |
| 1528 | 1.4.2.3.1.2.5.1 | SIT-B Settlement Testing Cycle 2 |  | 70d | 2025-03-10 | 2025-06-13 | 1545FS+10d |  |  |  | 2024-06-17 | 2024-09-20 | 0d |  |  | 32232d |  | start no earlier than 2024-06-17 | SI Test | SIT | 80.33 | 6.12 | Red | Stuart Scott | RED |  |  |  |  |  |  |
| 1529 | 1.4.2.3.1.2.5.2 | **SIT-B Settlement Testing Cycle 3** |  | 100d? | 2024-10-07 A | 2025-02-21 | 1365 | 58% | 42.11d? |  | 2024-10-07 | 2024-12-20 | 0d |  |  | 32237d | 0d |  | SI Test | SIT | -24.67 | 6.12 | Overdue Start | Stuart Scott | GREEN |  |  |  |  |  |  |
| 1530 | 1.4.2.3.1.2.5.2.1 | Sprint 5 |  | 20d? | 2024-10-07 A | 2024-11-01 A |  | 100% |  |  | 2024-10-07 | 2024-11-01 | 0d |  |  |  |  |  | SI Test | SIT |  | 6.12 | Complete | Stuart Scott | COMPLETE |  |  |  |  |  |  |
| 1531 | 1.4.2.3.1.2.5.2.2 | Sprint 5 Review (Flexibility Window Checkpoint) | milestone | 0d | 2024-11-04 A | 2024-11-04 A | 1530SS+21d | 100% |  |  | 2024-11-04 | 2024-11-04 | 0d |  |  |  |  |  | SI Test | SIT |  | 6.12 | Complete | Stuart Scott | COMPLETE |  |  |  |  |  |  |
| 1532 | 1.4.2.3.1.2.5.2.3 | Sprint 6 |  | 10d? | 2024-11-04 A | 2024-11-15 A | 1530 | 100% |  |  | 2024-11-04 | 2024-11-15 | 0d |  |  |  |  |  | SI Test | SIT |  | 6.12 | Complete | Stuart Scott | COMPLETE |  |  |  |  |  |  |
| 1533 | 1.4.2.3.1.2.5.2.4 | Sprint 6 Review (Pre Christmas Contingency Decision Point) | milestone | 0d | 2024-11-18 A | 2024-11-18 A | 1532SS+11d | 100% |  |  | 2024-11-18 | 2024-11-18 | 0d |  |  |  |  |  | SI Test | SIT |  | 6.12 | Complete | Stuart Scott | COMPLETE |  |  |  |  |  |  |
| 1534 | 1.4.2.3.1.2.5.2.5 | Sprint 7 |  | 10d? | 2024-11-18 A | 2024-11-29 A | 1532 | 100% |  |  | 2024-11-18 | 2024-11-29 | 0d |  |  |  |  |  | SI Test | SIT |  | 6.12 | Complete | Stuart Scott | COMPLETE |  |  |  |  |  |  |
| 1535 | 1.4.2.3.1.2.5.2.6 | Sprint 7 Review (Post Christmas Contingency Decision Point) | milestone | 0d | 2024-12-02 A | 2024-12-02 A | 1534SS+11d | 100% |  |  | 2024-12-02 | 2024-12-02 | 0d |  |  |  |  |  | SI Test | SIT |  | 6.12 | Complete | Stuart Scott | COMPLETE |  |  |  |  |  |  |
| 1536 | 1.4.2.3.1.2.5.2.7 | Sprint 8 |  | 15d | 2024-12-02 A | 2024-12-20 A | 1534 | 100% |  |  | 2024-12-02 | 2024-12-20 | 0d |  |  |  |  |  | SI Test | SIT |  | 6.15 | Complete | Stuart Scott | COMPLETE |  |  |  |  |  |  |
| 1537 | 1.4.2.3.1.2.5.2.8 | Post-Christmas Stabilisation |  | 5d | 2025-01-06 | 2025-01-10 | 1536FS+10d |  |  |  | 2025-01-06 | 2025-01-10 | 0d |  |  | 32267d |  |  | SI Test | SIT | 17.33 | 6.15 | Green | Stuart Scott | GREEN |  |  |  |  |  |  |
| 1538 | 1.4.2.3.1.2.5.2.9 | Sprint 9 |  | 10d | 2025-01-06 | 2025-01-17 | 1536FS+10d |  |  |  | 2025-01-13 | 2025-01-17 |  |  |  | 31603d | 0d |  | SI Test | SIT | 17.33 | 6.15 | Green |  | GREEN |  |  |  |  |  |  |
| 1539 | 1.4.2.3.1.2.5.2.10 | Sprint 9 Review | milestone | 0d | 2025-01-20 | 2025-01-20 | 1538FS+1d |  |  |  | 2025-01-20 | 2025-01-20 |  |  |  | 32261d |  |  | SI Test | SIT | 31.71 | 6.15 | Green |  | GREEN |  |  |  |  |  |  |
| 1540 | 1.4.2.3.1.2.5.2.11 | Sprint 10 |  | 10d | 2025-01-20 | 2025-01-31 | 1538 |  |  |  | 2025-01-20 | 2025-01-31 |  |  |  | 31603d | 0d |  | SI Test | SIT | 31.33 | 6.15 | Green |  | GREEN |  |  |  |  |  |  |
| 1541 | 1.4.2.3.1.2.5.2.12 | Sprint 10 Review | milestone | 0d | 2025-02-03 | 2025-02-03 | 1540FS+1d |  |  |  | 2025-02-03 | 2025-02-03 |  |  |  | 32251d |  |  | SI Test | SIT | 45.71 | 6.15 | Green |  | GREEN |  |  |  |  |  |  |
| 1542 | 1.4.2.3.1.2.5.2.13 | Sprint 11 |  | 10d | 2025-02-03 | 2025-02-14 | 1540 |  |  |  | 2025-02-03 | 2025-02-14 |  |  |  | 31603d | 0d |  | SI Test | SIT | 45.33 | 6.15 | Green |  | GREEN |  |  |  |  |  |  |
| 1543 | 1.4.2.3.1.2.5.2.14 | Sprint 11 Review | milestone | 0d | 2025-02-14 | 2025-02-14 | 1542 |  |  |  | 2025-02-14 | 2025-02-14 |  |  |  | 31603d | 0d |  | SI Test | SIT | 56.71 | 6.15 | Green |  | GREEN |  |  |  |  |  |  |
| 1544 | 1.4.2.3.1.2.5.2.15 | Sprint 12 |  | 5d | 2025-02-17 | 2025-02-21 | 1543 |  |  |  | 2025-02-17 | 2025-02-21 |  |  |  | 31603d | 0d |  | SI Test | SIT | 59.33 | 6.15 | Green |  | GREEN |  |  |  |  |  |  |
| 1545 | 1.4.2.3.1.2.5.2.16 | End of Settlement Testing Cycle 3 | milestone | 0d | 2025-02-21 | 2025-02-21 | 1544 |  |  |  | 2025-02-21 | 2025-02-21 | 0d |  |  | 31603d | 0d |  | SI Test | SIT | 63.71 | 6.15 | Green | Stuart Scott | GREEN | T3-TE-0140 | SITAG | T3 |  |  |  |
| 1546 | 1.4.2.3.1.2.5.3 | SIT-A CoS Settlement Testing |  | 20d? | 2025-05-19 | 2025-06-13 | 1429 |  |  |  | 2025-05-19 | 2025-06-13 | 0d |  |  | 27d | 0d |  | SI Test | SIT | 150.33 | 6.15 | Green | Stuart Scott | GREEN |  |  |  |  |  |  |
| 1547 | 1.4.2.3.1.2.6 | **SIT Functional MVC Regression Testing (code freeze)** |  | 40d? | 2025-06-16 | 2025-08-08 |  |  |  |  | 2025-06-16 | 2025-08-08 | 45d | 2024-11-04 | 2025-01-03 | 31578d |  |  | PP | SIT | 84.33 | 6.15 | Red | Roger Robar |  |  |  |  | SI Test | Systems Integration Testing (SIT) |  |
| 1548 | 1.4.2.3.1.2.6.1 | Regression Test Execution Start |  | 1d | 2025-06-16 | 2025-06-16 | 1429, 1546 |  |  |  | 2025-06-16 | 2025-06-16 | 0d |  |  | 32231d |  |  | SI Test | SIT | 178.33 | 6.15 | Green | Roger Robar | GREEN | T2-TE-1250 | SITAG | T2 |  |  |  |
| 1549 | 1.4.2.3.1.2.6.2 | Regression Sprint 1 |  | 10d? | 2025-06-16 | 2025-06-27 | 1546, 1423 |  |  |  | 2025-06-16 | 2025-06-27 | 0d |  |  | 31578d | 0d |  | SI Test | SIT | 178.33 | 6.14 | Green | Roger Robar | GREEN |  |  |  |  |  |  |
| 1550 | 1.4.2.3.1.2.6.3 | Regression Sprint 2 |  | 15d | 2025-06-30 | 2025-07-18 | 1549 |  |  |  | 2025-06-30 | 2025-07-18 | 0d |  |  | 31578d | 0d |  | SI Test | SIT | 192.33 | 6.15 | Green | Roger Robar | GREEN |  |  |  |  |  |  |
| 1551 | 1.4.2.3.1.2.6.4 | Regression Sprint 3 |  | 15d | 2025-07-21 | 2025-08-08 | 1550 |  |  |  | 2025-07-21 | 2025-08-08 | 0d |  |  | 31578d | 0d |  | SI Test | SIT | 213.33 | 6.15 | Green | Roger Robar | GREEN |  |  |  |  |  |  |
| 1552 | 1.4.2.3.1.2.7 | SIT Functional Testing End (Minimum Viable Cohort) (incl. confirmation that PPs have submitted their Test Completion Reports to Programme for assurance) | milestone | 0d | 2025-08-08 | 2025-08-08 | 1551 |  |  |  | 2025-08-08 | 2025-08-08 | 0d | 2025-01-03 | 2025-01-03 | 31578d | 0d | start no earlier than 2025-03-14 | SI Test | SIT | 231.71 | 6.1 | Green | Roger Robar | GREEN | T3-TE-0046 | SITAG | T3 | PP | Systems Integration Testing (SIT) | MHHS-ART072 |
| 1553 | 1.4.2.3.1.2.8 | Assurance of PPs Test Completion Reports |  | 25d | 2025-07-14 | 2025-08-15 | 1552FF+5d |  |  |  | 2025-07-14 | 2025-08-15 | 30d | 2024-12-02 | 2025-01-10 | 31578d | 0d |  | SI Test | SIT | 206.33 | 6.1 | Green | Roger Robar | GREEN |  |  |  | PP | Systems Integration Testing (SIT) |  |

Notes:
- 1545: 11/12/24 - This milestone will be missed because the velocity of Settlement testing means Sprint 8 will not be completed by 20/12/24 as per the baseline. Options on how to resolve this to be discussed and agreed by SITAG on 18/12/24 and updates to the plan will be made to reflect that.
- 1548: 27/11/24 - Programme is working to add dependencies and assign milestone ID which will go to SITAG for approval.
- 1550: 18/12/24 - Duration extended so that Regression end date in the plan is 08/08/25, as per agreed timelines.
- 1551: 18/12/24 - End date has moved to 08/08/25, as per agreed timelines.

| ID | WBS | Task | Type | Duration | Start | Finish | Predecessors | Complete | Remaining | Actual start | Actual finish | Baseline start | Baseline finish | Baseline duration | Baseline 1 start | Baseline 1 finish | Total slack | Free slack | Constraint | Baseline cost | Responsible | Involved | Text9 | Update Version | MHHS Resource Name | MHHS Programme Phase | Task Status | Sched Status | RAG | Artefact ID | Milestone ID | Text29 | Tier |
| --- | --- | --- | --- | --- | --- | --- | --- | --- | --- | --- | --- | --- | --- | --- | --- | --- | --- | --- | --- | --- | --- | --- | --- | --- | --- | --- | --- | --- | --- | --- | --- | --- | --- |
| 1554 | 1.4.2.3.1.2.9 | **SIT Functional Test Completion Report (Minimum Viable Cohort)** |  | 20d | 2025-07-21 | 2025-08-15 |  |  |  |  |  | 2025-07-21 | 2025-08-15 | 20d | 2024-12-16 | 2025-01-10 | 31578d |  |  |  | N/A | N/A | SIT | 6.1 | N/A | Systems Integration Testing (SIT) |  |  |  |  |  |  |  |
| 1555 | 1.4.2.3.1.2.9.1 | Develop document |  | 15d | 2025-07-21 | 2025-08-08 | 1552FF |  |  |  |  | 2025-07-21 | 2025-08-08 | 15d | 2024-12-16 | 2025-01-03 | 31578d | 0d |  |  | SI Test |  | SIT | 6.1 | Roger Robar | Systems Integration Testing (SIT) | 213.33 | Green | GREEN |  |  |  |  |
| 1556 | 1.4.2.3.1.2.9.2 | Review & agree document |  | 5d | 2025-08-11 | 2025-08-15 | 1555, 1553FF |  |  |  |  | 2025-08-11 | 2025-08-15 | 5d | 2025-01-06 | 2025-01-10 | 31578d | 0d |  |  | SI Test | PP,IPA | SIT | 6.1 | Roger Robar | Systems Integration Testing (SIT) | 234.33 | Green | GREEN |  |  |  |  |
| 1557 | 1.4.2.3.1.2.9.3 | SIT Functional Testing Test Completion Report (Minimum Viable Cohort) Approved | milestone | 0d | 2025-08-15 | 2025-08-15 | 1556FF |  |  |  |  | 2025-08-15 | 2025-08-15 | 0d | 2025-01-17 | 2025-01-17 | 31578d | 0d |  |  | SI Test | PP | SIT | 6.1 | Roger Robar | Systems Integration Testing (SIT) | 238.71 | Green | GREEN | MHHS-ART072 | T2-TE-0850 | SITAG | T2 |
| 1558 | 1.4.2.3.2 | **Helix E2E Settlement Testing** |  | 86d? | 2025-02-07 | 2025-06-06 |  |  |  |  |  | 2025-01-06 | 2025-04-04 | 0d |  |  | 32237d |  |  |  | SI Test |  | SIT | 6.0 | Helix |  | -689.67 | Overdue Start |  |  |  |  |  |
| 1559 | 1.4.2.3.2.1 | Programme agreement into Settlement Testing |  | 1d? | 2025-02-07 | 2025-02-07 |  |  |  |  |  | 2025-02-07 | 2025-02-07 |  |  |  | 32322d |  | start no earlier than 2025-02-07 |  | SI Test |  | SIT | 6.15 |  |  | 49.33 | Green | GREEN |  |  |  |  |
| 1560 | 1.4.2.3.2.2 | Helix E2E Settlement Testing Execution |  | 65d | 2025-03-10 | 2025-06-06 | 1529FS+10d |  |  |  |  | 2025-01-06 | 2025-04-04 | 0d |  |  | 32237d | 0d |  |  | SI Test |  | SIT | 6.0 | Helix |  | 80.33 | Red | RED |  |  |  |  |
| 1561 | 1.4.2.3.2.3 | Helix E2E Settlement Testing Execution Complete | milestone | 0d | 2025-06-06 | 2025-06-06 | 1560 |  |  |  |  | 2025-04-04 | 2025-04-04 | 0d |  |  | 32237d |  |  |  | SI Test |  | SIT | 6.0 | Helix |  | 168.71 | Red | RED |  |  |  |  |
| 1562 | 1.4.2.3.2.4 | MHHSP Helix E2E Testing Assurance |  | 65d | 2025-03-10 | 2025-06-06 | 1529FS+10d |  |  |  |  | 2025-01-06 | 2025-04-04 | 0d |  |  | 32237d | 0d |  |  | SI Test |  | SIT | 6.0 | Helix |  | 80.33 | Red | RED |  |  |  |  |
| 1563 | 1.4.2.3.2.5 | MHHSP Helix E2E Testing Assurance Complete | milestone | 0d | 2025-06-06 | 2025-06-06 | 1562 |  |  |  |  | 2025-04-04 | 2025-04-04 | 0d |  |  | 32237d |  |  |  | SI Test |  | SIT | 6.0 | Helix |  | 168.71 | Red | RED |  |  |  |  |
| 1564 | 1.4.2.3.3 | **SIT Migration Testing (MVC)** |  | 380d? | 2024-03-11 A | 2025-08-22 |  | 49% | 194.94d? |  |  | 2024-03-11 | 2025-08-22 | 155d | 2024-06-10 | 2024-10-18 | 32182d |  |  | -0 | SI Test | N/A | SIT | 6.0 | Helix | Systems Integration Testing (SIT) |  | Overdue | GREEN |  |  | SITAG |  |
| 1565 | 1.4.2.3.3.1 | SIT Migration Testing Start | milestone | 0d? | 2024-03-11 | 2024-03-11 |  |  |  |  |  | 2024-03-11 | 2024-03-11 | 0d |  |  | 32562d |  | start no earlier than 2024-03-11 |  | SI Test |  | SIT | 6.0 | Helix |  | -283.67 | Overdue Start | RED |  |  |  |  |
| 1566 | 1.4.2.3.3.2 | **SIT Migration Testing Execution (Minimum Viable Cohort)** |  | 380d? | 2024-03-11 A | 2025-08-22 |  | 49% | 194.94d? |  |  | 2024-03-11 | 2025-08-22 | 0d |  |  | 32182d |  |  |  | SI Test |  | SIT | 6.0 | Helix |  | -685.67 | Overdue Start | RED |  |  | SITAG |  |
| 1567 | 1.4.2.3.3.2.1 | **Cycle 1 (Full Cycle)** |  | 70d? | 2024-03-11 A | 2024-06-14 A |  | 100% |  |  |  | 2024-03-11 | 2024-06-14 | 0d |  |  |  |  |  |  | SI Test |  | SIT | 6.0 | Helix |  | -685.67 | Overdue Start |  |  |  |  |  |
| 1568 | 1.4.2.3.3.2.1.1 | Test Execution |  | 55d? | 2024-03-11 A | 2024-05-24 A |  | 100% |  |  |  | 2024-03-11 | 2024-05-24 | 0d |  |  |  |  | start no earlier than 2024-03-11 |  | SI Test |  | SIT | 6.0 | Helix |  |  | Complete | COMPLETE |  |  |  |  |
| 1569 | 1.4.2.3.3.2.1.2 | Defect resolution, assurance, review, data& environments maintenance |  | 15d? | 2024-05-27 A | 2024-06-14 A |  | 100% |  |  |  | 2024-05-27 | 2024-06-14 | 0d |  |  |  |  | finish no earlier than 2024-06-14 |  | SI Test |  | SIT | 6.0 | Helix |  |  | Complete | COMPLETE |  |  |  |  |
| 1570 | 1.4.2.3.3.2.2 | **Cycle 2 (Defect retests and targeted regression testing)** |  | 80d? | 2024-03-11 | 2024-06-28 |  | 100% |  | 2024-06-17 | 2024-10-04 | 2024-03-11 | 2024-06-28 | 0d |  |  |  |  |  |  | SI Test |  | SIT | 6.0 | Helix |  | -685.67 | Overdue Start |  |  |  |  |  |
| 1571 | 1.4.2.3.3.2.2.1 | Test Execution |  | 70d? | 2024-06-17 A | 2024-09-20 A | 1569 | 100% |  |  |  | 2024-06-17 | 2024-09-20 | 0d |  |  |  |  | start no earlier than 2024-06-17 |  | SI Test |  | SIT | 6.0 | Helix |  |  | Complete | COMPLETE |  |  |  |  |
| 1572 | 1.4.2.3.3.2.2.2 | Defect resolution, assurance, review, data & environments maintenance |  | 10d? | 2024-09-23 A | 2024-10-04 A | 1571 | 100% |  |  |  | 2024-09-23 | 2024-10-04 | 0d |  |  |  |  | finish no earlier than 2024-10-04 |  | SI Test |  | SIT | 6.0 | Helix |  |  | Complete | COMPLETE |  |  |  |  |
| 1573 | 1.4.2.3.3.2.3 | **SIT Functional Testing back-up progress risk-assessment** |  | 70d? | 2024-06-17 | 2024-09-20 |  |  |  |  |  | 2024-06-17 | 2024-09-20 | 0d |  |  |  |  |  |  | SI Test |  | SIT | 6.0 | Helix |  | -685.67 | Overdue Start | RED |  |  |  |  |
| 1574 | 1.4.2.3.3.2.3.1 | Back-up risk-assessment of SIT Migration progress to assess whether Qualification Execution can start early |  | 15d? | 2024-10-07 | 2024-10-25 | 1572 |  |  |  |  | 2024-10-07 | 2024-10-25 | 0d |  |  | 32392d | 0d | finish no earlier than 2024-10-04 |  | SI Test |  | SIT | 6.0 | Helix |  | -73.67 | Overdue Start | RED |  |  |  |  |
| 1575 | 1.4.2.3.3.2.3.2 | Back-up SITAG decision on early Qualification Testing Execution start | milestone | 0d? | 2024-11-01 | 2024-11-01 | 1574FS+5d |  |  |  |  | 2024-11-01 | 2024-11-01 | 0d |  |  | 32392d |  |  |  | SI Test |  | SIT | 6.0 | Helix |  | -48.29 | Green | RED |  |  |  |  |
| 1576 | 1.4.2.3.3.2.4 | **Cycle 3 (Defect retests and targeted regression testing)** |  | 135d? | 2024-10-21 A | 2025-04-25 |  | 28% | 97.5d? |  |  | 2024-10-21 | 2025-04-25 | 0d |  |  | 32267d |  |  |  | SI Test |  | SIT | 6.0 | Roger Robar |  | -685.67 | Overdue Start | RED |  |  |  |  |
| 1577 | 1.4.2.3.3.2.4.1 | Sprint 5 |  | 10d | 2024-10-21 A | 2024-11-01 A | 140FS-1d | 100% |  |  |  | 2024-10-21 | 2024-11-01 | 0d |  |  |  |  | start no earlier than 2024-10-21 |  | SI Test |  | SIT | 6.0 | Roger Robar |  |  | Complete | COMPLETE |  |  |  |  |
| 1578 | 1.4.2.3.3.2.4.2 | Sprint 6 |  | 10d | 2024-11-04 A | 2024-11-15 A | 1577 | 100% |  |  |  | 2024-11-04 | 2024-11-15 | 0d |  |  |  |  | start no earlier than 2024-11-04 |  | SI Test |  | SIT | 6.0 | Roger Robar |  |  | Complete | COMPLETE |  |  |  |  |
| 1579 | 1.4.2.3.3.2.4.3 | Sprint 7 |  | 10d | 2024-11-18 A | 2024-11-29 A | 1578 | 100% |  |  |  | 2024-11-18 | 2024-11-29 | 0d |  |  |  |  |  |  | SI Test |  | SIT | 6.0 | Roger Robar |  |  | Complete | COMPLETE |  |  |  |  |
| 1580 | 1.4.2.3.3.2.4.4 | Sprint 8 |  | 15d | 2024-12-02 A | 2024-12-20 | 1579 | 50% | 7.5d |  |  | 2024-12-02 | 2024-12-20 | 0d |  |  | 27d | 0d | finish no earlier than 2024-11-15 |  | SI Test |  | SIT | 6.0 | Roger Robar |  |  | Green | GREEN |  |  |  |  |
| 1581 | 1.4.2.3.3.2.4.5 | Christmas downtime |  | 10d | 2024-12-23 | 2025-01-03 | 1580 |  |  |  |  | 2024-12-23 | 2025-01-03 | 0d |  |  | 27d | 0d | finish no earlier than 2024-11-29 |  | SI Test |  | SIT | 6.0 | Roger Robar |  | 3.33 | Green | GREEN |  |  |  |  |
| 1582 | 1.4.2.3.3.2.4.6 | Sprint 9 |  | 10d | 2025-01-06 | 2025-01-17 | 1581 |  |  |  |  | 2025-01-06 | 2025-01-17 | 0d |  |  | 27d | 0d | finish no earlier than 2024-12-20 |  | SI Test |  | SIT | 6.0 | Roger Robar |  | 17.33 | Green | GREEN |  |  |  |  |
| 1583 | 1.4.2.3.3.2.4.7 | Sprint 10 |  | 10d | 2025-01-20 | 2025-01-31 | 1582 |  |  |  |  | 2025-01-20 | 2025-01-31 | 0d |  |  | 27d | 0d | finish no earlier than 2025-01-03 |  | SI Test |  | SIT | 6.0 | Roger Robar |  | 31.33 | Green | GREEN |  |  |  |  |
| 1584 | 1.4.2.3.3.2.4.8 | Sprint 11 |  | 10d | 2025-02-03 | 2025-02-14 | 1583 |  |  |  |  | 2025-02-03 | 2025-02-14 | 0d |  |  | 27d | 0d | finish no earlier than 2025-01-17 |  | SI Test |  | SIT | 6.0 | Roger Robar |  | 45.33 | Green | GREEN |  |  |  |  |
| 1585 | 1.4.2.3.3.2.4.9 | Sprint 12 |  | 10d | 2025-02-17 | 2025-02-28 | 1584 |  |  |  |  | 2025-02-17 | 2025-02-28 | 0d |  |  | 27d | 0d | finish no earlier than 2025-01-31 |  | SI Test |  | SIT | 6.0 | Roger Robar |  | 59.33 | Green | GREEN |  |  |  |  |
| 1586 | 1.4.2.3.3.2.4.10 | Sprint 13 |  | 10d | 2025-03-03 | 2025-03-14 | 1585 |  |  |  |  | 2025-03-03 | 2025-03-14 | 0d |  |  | 27d | 0d |  |  | SI Test |  | SIT | 6.1 | Roger Robar |  | 73.33 | Green | GREEN |  |  |  |  |
| 1587 | 1.4.2.3.3.2.4.11 | Sprint 14 (RTTM Gap Analysis + CR056) |  | 10d? | 2025-03-17 | 2025-03-28 | 1586 |  |  |  |  | 2025-03-17 | 2025-03-28 | 0d |  |  | 27d | 0d |  |  | SI Test |  | SIT | 6.1 | Roger Robar |  | 87.33 | Green | GREEN |  |  |  |  |
| 1588 | 1.4.2.3.3.2.4.12 | Sprint 15 (Contingency 1) |  | 10d? | 2025-03-31 | 2025-04-11 | 1587 |  |  |  |  | 2025-03-31 | 2025-04-11 | 0d |  |  | 27d | 0d |  |  | SI Test |  | SIT | 6.1 | Roger Robar |  | 101.33 | Green | GREEN |  |  |  |  |
| 1589 | 1.4.2.3.3.2.4.13 | Sprint 16 (Contingency 2) |  | 10d? | 2025-04-14 | 2025-04-25 | 1588 |  |  |  |  | 2025-04-14 | 2025-04-25 | 0d |  |  | 27d | 0d |  |  | SI Test |  | SIT | 6.1 | Roger Robar |  | 115.33 | Green | GREEN |  |  |  |  |
| 1590 | 1.4.2.3.3.2.4.14 | SIT Migration Cycle 3 Complete | milestone | 0d | 2025-04-25 | 2025-04-25 | 1589 |  |  |  |  | 2025-04-25 | 2025-04-25 |  |  |  | 32267d |  |  |  | SI Test |  | SIT | 6.1 | Roger Robar |  | 126.71 | Green | GREEN |  | T2-TE-1200 |  | T2 |

Notes:
- 1574: 13/11/24 - 8/9 prerequisite test complete, final test relies on deployment of IR8.4.
- 1590: 25/11/24 - New milestone added by Programme, awaiting formal SITAG approval. Programme will also be adding in dependencies.

| ID | WBS | Task | Type | Duration | Start | Finish | Predecessors | Baseline start | Baseline finish | Baseline duration | Baseline 1 start | Baseline 1 finish | Total slack | Free slack | Constraint | Responsible | Text9 | Task Status | Update Version | Sched Status | MHHS Resource Name | RAG | Involved | Artefact ID | MHHS Programme Phase | Text29 | Tier | Future RAG | Milestone ID | Guidance |
| --- | --- | --- | --- | --- | --- | --- | --- | --- | --- | --- | --- | --- | --- | --- | --- | --- | --- | --- | --- | --- | --- | --- | --- | --- | --- | --- | --- | --- | --- | --- |
| 1591 | 1.4.2.3.3.2.5 | **SIT Migration MVC Regression Testing (code freeze)** |  | 35d? | 2025-06-16 | 2025-08-01 |  | 2025-06-16 | 2025-08-01 | 0d |  |  | 32182d |  |  | SI Test | SIT | -685.67 | 6.0 | Overdue Start | Roger Robar |  |  |  |  |  |  |  |  |  |
| 1592 | 1.4.2.3.3.2.5.1 | Regression Sprint 1 |  | 10d? | 2025-06-16 | 2025-06-27 | 1546 | 2025-06-16 | 2025-06-27 | 0d |  |  | 32182d | 0d |  | SI Test | SIT | 178.33 | 6.0 | Green | Roger Robar | GREEN |  |  |  |  |  |  |  |  |
| 1593 | 1.4.2.3.3.2.5.2 | Regression Sprint 2 |  | 10d? | 2025-06-30 | 2025-07-11 | 1592 | 2025-06-30 | 2025-07-11 | 0d |  |  | 32182d | 0d |  | SI Test | SIT | 192.33 | 6.0 | Green | Roger Robar | GREEN |  |  |  |  |  |  |  |  |
| 1594 | 1.4.2.3.3.2.5.3 | Regression Sprint 3 |  | 15d? | 2025-07-14 | 2025-08-01 | 1593 | 2025-07-14 | 2025-08-01 | 0d |  |  | 32182d | 0d |  | SI Test | SIT | 206.33 | 6.0 | Green | Roger Robar | GREEN |  |  |  |  |  |  |  |  |
| 1595 | 1.4.2.3.3.2.5.4 | SIT Migration Testing End (Minimum Viable Cohort) (incl. confirmation that PPs have submitted their Test Completion Reports to Programme for assurance) | milestone | 0d | 2025-08-01 | 2025-08-01 | 1594 | 2025-08-01 | 2025-08-01 | 0d |  |  | 32182d | 0d | start no earlier than 2025-06-20 | SI Test | SIT | 224.71 | 6.0 | Green | Roger Robar | GREEN |  |  |  |  |  |  |  |  |
| 1596 | 1.4.2.3.3.2.6 | **SIT Migration Test Completion Report (Minimum Viable Cohort)** |  | 25d | 2025-07-14 | 2025-08-15 | 1070, 972, 976, 983, 989, 995 | 2025-07-14 | 2025-08-15 | 0d | 2024-06-10 | 2024-06-10 | 32182d |  |  | SI Test | SIT |  | 6.1 | Complete |  |  | PP | MHHS-ART076 | Systems Integration Testing (SIT) | SITAG | T3 |  |  |  |
| 1597 | 1.4.2.3.3.2.6.1 | Develop document |  | 15d | 2025-07-14 | 2025-08-01 | 1595FF | 2025-07-14 | 2025-08-01 | 85d | 2024-06-10 | 2024-10-04 | 32182d | 0d |  | SI Test | SIT | 206.33 | 6.1 | Green | Roger Robar | GREEN | PP |  | Systems Integration Testing (SIT) |  |  | D24E - Migration Test Completion Report |  |  |
| 1598 | 1.4.2.3.3.2.6.2 | Review & agree document |  | 5d | 2025-08-04 | 2025-08-08 | 1597 | 2025-08-04 | 2025-08-08 | 10d | 2024-10-21 | 2024-11-01 | 32182d | 0d |  | SI Test | SIT | 227.33 | 6.1 | Green | Roger Robar | GREEN | PP |  | Systems Integration Testing (SIT) |  |  |  |  |  |
| 1599 | 1.4.2.3.3.2.6.3 | SIT Migration Testing Test Completion Report (Minimum Viable Cohort) Approved | milestone | 0d | 2025-08-15 | 2025-08-15 | 1598FS+5d | 2025-08-15 | 2025-08-15 | 45d |  |  | 32182d | 0d |  | SI Test | SIT | 238.71 | 6.1 | Green |  | GREEN |  |  |  | SITAG | T2 |  | T2-TE-0800 |  |
| 1600 | 1.4.2.3.3.2.7 | SIT Migration Testing End (Minimum Viable Cohort) (incl. confirmation that PPs have submitted their Test Completion Reports to Programme for assurance) | milestone | 0d | 2025-08-15 | 2025-08-15 | 1597FF, 1599 | 2025-08-15 | 2025-08-15 | 0d | 2024-10-04 | 2024-10-04 | 32182d | 0d | start no earlier than 2025-03-14 | SI Test | SIT | 238.71 | 6.1 | Green | Roger Robar | GREEN | PP | MHHS-ART076 | Systems Integration Testing (SIT) | SITAG | T3 |  | T3-TE-0043 |  |
| 1601 | 1.4.2.3.3.2.8 | Assurance of PPs Test Completion Reports |  | 30d | 2025-07-14 | 2025-08-22 | 1600FF+5d | 2025-07-14 | 2025-08-22 | 30d | 2024-09-02 | 2024-10-11 | 32182d |  |  | SI Test | SIT | 206.33 | 6.1 | Green | Roger Robar | GREEN | PP |  | Systems Integration Testing (SIT) |  |  |  |  |  |
| 1602 | 1.4.2.3.4 | **SIT Non-Functional Testing (all SIT PPs)** |  | 71d? | 2025-02-28 | 2025-06-06 |  | 2025-02-28 | 2025-07-10 | 100d | 2024-09-02 | 2025-01-17 | 31603d |  |  | N/A | SIT |  | 6.1 |  | N/A |  | N/A |  | Systems Integration Testing (SIT) | SITAG |  |  |  |  |
| 1603 | 1.4.2.3.4.1 | Theme 1 (Helix and DIP Volume Testing) Start | milestone | 0d? | 2025-02-28 | 2025-02-28 | 1144, 1160 | 2025-02-28 | 2025-02-28 | 0d |  |  | 31603d | 0d | finish no earlier than 2025-01-13 | SIT Participant | SIT | 70.71 | 6.15 | Green | Roger Robar | GREEN |  |  |  | SITAG | T3 |  | T3-TE-0124 |  |
| 1604 | 1.4.2.3.4.2 | Theme 1 (Helix and DIP Volume Testing) Execution |  | 15d? | 2025-02-28 | 2025-03-20 | 1603FS-1d | 2025-02-28 | 2025-03-20 | 0d |  |  | 31603d | 0d | start no earlier than 2025-01-13 |  | SIT | 70.33 | 6.15 | Green | Roger Robar | GREEN |  |  |  |  |  |  |  |  |
| 1605 | 1.4.2.3.4.3 | Theme 2 SIT Non-Functional Testing Start | milestone | 0d | 2025-03-31 | 2025-03-31 | 1187, 1507, 1077, 1081, 1088, 1094, 1100, 1146, 1545, 1169FS+1d | 2025-03-31 | 2025-03-31 | 0d | 2024-09-02 | 2024-09-02 | 31672d | 0d |  | SI Test | SIT | 101.71 | 6.15 | Green | Roger Robar | GREEN | PP | MHHS-ART079 | Systems Integration Testing (SIT) | SITAG | T3 |  | T3-TE-0040 | 12/8/24: needs to be 7/10/24 |
| 1606 | 1.4.2.3.4.4 | Theme 2 SIT Non-Functional Testing Execution |  | 40d | 2025-03-31 | 2025-05-23 | 1605SS-1d | 2025-05-01 | 2025-06-25 | 90d | 2024-09-02 | 2025-01-03 | 31633d | 0d |  | SI Test | SIT | 101.33 | 6.15 | Green | Roger Robar | GREEN | PP |  | Systems Integration Testing (SIT) |  |  | D24D - NF Test Completion Report |  |  |
| 1607 | 1.4.2.3.4.5 | Theme 3 SIT Non-Functional Testing Start |  | 1d? | 2025-03-31 | 2025-03-31 | 1146, 1169 | 2025-05-02 | 2025-05-02 | 0d |  |  | 31633d | 0d |  |  | SIT | 101.33 | 6.15 | Green | Roger Robar | GREEN |  |  |  |  |  |  |  |  |
| 1608 | 1.4.2.3.4.6 | Theme 3 SIT Non-Functional Testing Execution |  | 40d? | 2025-03-31 | 2025-05-23 | 1607SS | 2025-05-02 | 2025-06-26 | 0d |  |  | 31633d | 0d |  |  | SIT | 101.33 | 6.15 | Green | Roger Robar | GREEN |  |  |  |  |  |  |  |  |
| 1609 | 1.4.2.3.4.7 | SIT Non-Functional Testing End (all SIT PPs) (incl. confirmation that PPs have submitted their Test Completion Reports to Programme for assurance) | milestone | 0d | 2025-05-23 | 2025-05-23 | 1606FF, 1608FF | 2025-05-23 | 2025-05-23 | 0d | 2025-01-03 | 2025-01-03 | 31633d | 0d | start no earlier than 2025-05-23 | SI Test | SIT | 154.71 | 6.1 | Green | Roger Robar | GREEN | PP | MHHS-ART079 | Systems Integration Testing (SIT) | SITAG | T3 |  | T3-TE-0047 |  |
| 1610 | 1.4.2.3.4.8 | Assurance of PPs Test Completion Reports |  | 20d | 2025-05-05 | 2025-05-30 | 1609FF+5d | 2025-05-05 | 2025-05-30 | 30d | 2024-12-02 | 2025-01-10 | 31633d | 0d |  | SI Test | SIT | 136.33 | 6.1 | Green | Roger Robar | GREEN | PP |  | Systems Integration Testing (SIT) |  |  |  |  |  |
| 1611 | 1.4.2.3.4.9 | **SIT Non-Functional Testing Test Completion Report (all SIT PPs)** |  | 20d | 2025-05-05 | 2025-05-30 |  | 2025-05-02 | 2025-05-29 | 20d | 2024-12-16 | 2025-01-10 | 31633d |  |  | N/A | SIT |  | 6.1 |  | N/A |  | N/A |  | Systems Integration Testing (SIT) |  |  |  |  |  |
| 1612 | 1.4.2.3.4.9.1 | Develop document |  | 15d | 2025-05-05 | 2025-05-23 | 1609FF | 2025-05-05 | 2025-05-23 | 15d | 2024-12-16 | 2025-01-03 | 31633d | 0d |  | SI Test | SIT | 136.33 | 6.1 | Green | Roger Robar | GREEN |  |  | Systems Integration Testing (SIT) |  |  |  |  |  |
| 1613 | 1.4.2.3.4.9.2 | Review & agree document |  | 5d | 2025-05-26 | 2025-05-30 | 1612, 1610FF | 2025-05-26 | 2025-05-30 | 5d | 2025-01-06 | 2025-01-10 | 31633d | 0d |  | SI Test | SIT | 157.33 | 6.1 | Green | Roger Robar | GREEN | PP,IPA |  | Systems Integration Testing (SIT) |  |  |  |  |  |
| 1614 | 1.4.2.3.4.10 | SIT Non-Functional Testing Test Completion Report (all SIT PPs) Approved | milestone | 0d | 2025-06-06 | 2025-06-06 | 1613FF+5d | 2025-06-06 | 2025-06-06 | 0d | 2025-01-17 | 2025-01-17 | 31633d | 55d |  | SI Test | SIT | 168.71 | 6.1 | Green | Roger Robar | GREEN | PP | MHHS-ART079 | Systems Integration Testing (SIT) | SITAG | T2 |  | T2-TE-0900 |  |

Notes:
- 1603: 18/12/24 - SITAG approved the extension of Settlement testing and the postponement of NF / Ops data loads and testing, this date has been rebaselined to reflect this.
- 1604: 18/12/24 - SITAG approved the extension of Settlement testing and the postponement of NF / Ops data loads and testing, this date has been rebaselined to reflect this.
- 1605: 18/12/24 - SITAG approved the extension of Settlement testing and the postponement of NF / Ops data loads and testing, this date has been rebaselined to reflect this.
- 1606: 18/12/24 - SITAG approved the extension of Settlement testing and the postponement of NF / Ops data loads and testing, this date has been rebaselined to reflect this.
- 1607: 18/12/24 - SITAG approved the extension of Settlement testing and the postponement of NF / Ops data loads and testing, this date has been rebaselined to reflect this.
- 1608: 18/12/24 - SITAG approved the extension of Settlement testing and the postponement of NF / Ops data loads and testing, this date has been rebaselined to reflect this.

| ID | WBS | Task | Type | Duration | Start | Finish | Predecessors | Complete | Remaining | Baseline start | Baseline finish | Baseline duration | Baseline 1 start | Baseline 1 finish | Total slack | Free slack | Constraint | Baseline cost | Responsible | Involved | Text9 | Update Version | MHHS Resource Name | MHHS Programme Phase | Text29 | Task Status | Sched Status | RAG | Milestone ID | Tier | Artefact ID | Future RAG |
| --- | --- | --- | --- | --- | --- | --- | --- | --- | --- | --- | --- | --- | --- | --- | --- | --- | --- | --- | --- | --- | --- | --- | --- | --- | --- | --- | --- | --- | --- | --- | --- | --- |
| 1615 | 1.4.2.3.5 | **SIT Operational Testing (all SIT PPs)** |  | 120d? | 2025-02-03 | 2025-07-18 |  |  |  | 2025-02-03 | 2025-06-06 | 90d | 2024-10-07 | 2025-02-07 | 31603d |  |  |  | N/A | N/A | SIT | 5.0 | N/A | Systems Integration Testing (SIT) | SITAG |  |  |  |  |  |  |  |
| 1616 | 1.4.2.3.5.1 | **Non-SIT B Testing** |  | 25d? | 2025-02-03 | 2025-03-07 |  |  |  | 2025-02-03 | 2025-03-07 | 0d |  |  | 31688d |  |  |  |  |  | SIT |  |  |  | SITAG | -686.67 | Overdue Start |  |  |  |  |  |
| 1617 | 1.4.2.3.5.1.1 | SIT Operational Testing Start (Theme 3 - Batch 1 (Service Management)) | milestone | 0d? | 2025-02-03 | 2025-02-03 | 1334, 1274, 1275 |  |  | 2025-02-03 | 2025-02-03 | 0d |  |  | 31688d | 0d | start no earlier than 2025-02-03 |  | SI Test |  | SIT | 6.0 |  |  | SITAG | 45.33 | Green | GREEN | T3-TE-0121 | T3 |  |  |
| 1618 | 1.4.2.3.5.1.2 | SIT Operational Testing Execution Window (Theme 3 - Batch 1 (Service Management)) |  | 25d? | 2025-02-03 | 2025-03-07 | 1617 |  |  | 2025-02-03 | 2025-03-07 | 0d |  |  | 31688d | 85d | start no earlier than 2025-01-06 |  |  |  | SIT | 6.0 |  |  |  | 45.33 | Green | GREEN |  |  |  |  |
| 1619 | 1.4.2.3.5.2 | **SIT B Testing** |  | 70d? | 2025-03-31 | 2025-07-04 |  |  |  | 2025-02-07 | 2025-05-16 | 0d |  |  | 31603d |  |  |  |  |  | SIT | 6.15 |  |  |  | -686.67 | Overdue Start |  |  |  |  |  |
| 1620 | 1.4.2.3.5.2.1 | SIT Operational Testing Start (SIT B) | milestone | 0d | 2025-03-31 | 2025-03-31 | 1399, 1196, 1200, 1207, 1213, 1334, 1147, 1148, 1379FS+1d |  |  | 2025-03-31 | 2025-03-31 | 0d | 2024-10-07 | 2024-10-07 | 31603d | 0d |  |  |  | PP | SIT | 6.15 | Roger Robar | Systems Integration Testing (SIT) | SITAG | 101.71 | Green | GREEN | T3-TE-0042 | T3 | MHHS-ART073 MHHS-ART143 |  |
| 1621 | 1.4.2.3.5.2.2 | SIT Operational Testing Execution Theme 3 Batch 2 |  | 25d? | 2025-03-31 | 2025-05-02 | 1620FS-1d, 1320 |  |  | 2025-03-31 | 2025-05-02 | 0d |  |  | 31603d | 0d |  |  |  |  | SIT | 6.15 |  |  |  | 101.33 | Green | GREEN |  |  |  |  |
| 1622 | 1.4.2.3.5.2.3 | SIT Operational Testing Execution Theme 1 |  | 25d? | 2025-05-05 | 2025-06-06 | 1621 |  |  | 2025-05-05 | 2025-06-06 | 0d |  |  | 31603d | 0d |  |  |  |  | SIT | 6.15 |  |  |  | 136.33 | Green | GREEN |  |  |  |  |
| 1623 | 1.4.2.3.5.2.4 | SIT Operational Testing Execution Theme 2 |  | 20d? | 2025-06-09 | 2025-07-04 | 1622 |  |  | 2025-06-09 | 2025-07-04 | 0d |  |  | 31603d | 0d |  |  |  |  | SIT | 6.15 |  |  |  | 171.33 | Green | GREEN |  |  |  |  |
| 1624 | 1.4.2.3.5.3 | SIT Operational Testing End (all SIT PPs) (incl. confirmation that PPs have submitted their Test Completion Reports to Programme for assurance) | milestone | 0d | 2025-07-04 | 2025-07-04 | 1623, 1618 |  |  | 2025-07-11 | 2025-07-11 | 0d | 2025-01-24 | 2025-01-24 | 31603d | 0d |  |  |  | PP | SIT | 6.15 | Roger Robar | Systems Integration Testing (SIT) | SITAG | 196.71 | Green | GREEN | T3-TE-0050 | T3 | MHHS-ART081 |  |
| 1625 | 1.4.2.3.5.4 | Assurance of PPs Test Completion Reports |  | 30d | 2025-06-02 | 2025-07-11 | 1624FF+5d |  |  | 2025-06-09 | 2025-07-18 | 30d | 2024-12-23 | 2025-01-31 | 31603d | 0d |  |  | SI Test | PP | SIT | 6.15 | Roger Robar | Systems Integration Testing (SIT) |  | 164.33 | Green | GREEN |  |  |  |  |
| 1626 | 1.4.2.3.5.5 | **SIT Operational Testing Test Completion Report (all SIT PPs)** |  | 20d | 2025-06-16 | 2025-07-11 |  |  |  | 2025-06-23 | 2025-07-18 | 20d | 2025-01-06 | 2025-01-31 | 31603d |  |  |  | N/A | N/A | SIT | 6.15 | N/A | Systems Integration Testing (SIT) |  |  |  |  |  |  |  |  |
| 1627 | 1.4.2.3.5.5.1 | Develop document |  | 15d | 2025-06-16 | 2025-07-04 | 1624FF |  |  | 2025-06-23 | 2025-07-11 | 15d | 2025-01-06 | 2025-01-24 | 31603d | 0d |  |  | SI Test |  | SIT | 6.15 | Roger Robar | Systems Integration Testing (SIT) |  | 178.33 | Green | GREEN |  |  |  |  |
| 1628 | 1.4.2.3.5.5.2 | Review & agree document |  | 5d | 2025-07-07 | 2025-07-11 | 1627, 1625FF |  |  | 2025-07-14 | 2025-07-18 | 5d | 2025-01-27 | 2025-01-31 | 31603d | 0d |  |  | SI Test | PP,IPA | SIT | 6.15 | Roger Robar | Systems Integration Testing (SIT) |  | 199.33 | Green | GREEN |  |  |  |  |
| 1629 | 1.4.2.3.5.6 | SIT Operational Testing Test Completion Report (all SIT PPs) Approved | milestone | 0d | 2025-07-18 | 2025-07-18 | 1628FF+5d |  |  | 2025-07-25 | 2025-07-25 | 0d | 2025-02-07 | 2025-02-07 | 31603d | 25d |  |  | SI Test | PP | SIT | 6.15 | Roger Robar | Systems Integration Testing (SIT) | SITAG | 210.71 | Green | GREEN | T2-TE-0950 | T2 | MHHS-ART081 |  |
| 1630 | 1.4.2.3.6 | **SIT MVC Test Exit Report** |  | 20d | 2025-07-21 | 2025-08-15 |  |  |  | 2025-07-14 | 2025-08-08 | 20d | 2025-01-06 | 2025-01-31 | 32187d |  |  |  | N/A | N/A | SIT | 6.0 | N/A | Systems Integration Testing (SIT) |  |  |  |  |  |  |  |  |
| 1631 | 1.4.2.3.6.1 | Develop document |  | 15d | 2025-07-21 | 2025-08-08 | 1555FF |  |  | 2025-07-14 | 2025-08-01 | 15d | 2025-01-06 | 2025-01-24 | 32187d | 0d |  |  | SI Test |  | SIT | 6.0 | Roger Robar | Systems Integration Testing (SIT) |  | 213.33 | yellow | RED |  |  |  |  |
| 1632 | 1.4.2.3.6.2 | Review & agree document |  | 5d | 2025-08-11 | 2025-08-15 | 1631 |  |  | 2025-08-04 | 2025-08-08 | 5d | 2025-01-27 | 2025-01-31 | 32187d |  |  |  | SI Test | PP,IPA | SIT | 6.0 | Roger Robar | Systems Integration Testing (SIT) |  | 234.33 | yellow | RED |  |  |  |  |
| 1633 | 1.4.2.3.7 | SIT Minimum Viable Cohort Complete (SIT Minimum Viable Cohort Test Exit Report Approved) | milestone | 0d | 2025-08-22 | 2025-08-22 | 1498, 1557FS+5d, 1614, 1629 |  |  | 2025-08-22 | 2025-08-22 | 0d | 2025-02-07 | 2025-02-07 | 31578d | 0d |  |  | CPT | PP,IPA | SIT | 6.0 | Roger Robar | Systems Integration Testing (SIT) | PSG | 245.71 | Green | GREEN | T1-TE-2000 | T1 | MHHS-ART081 |  |
| 1634 | 1.4.2.4 | **SIT (non-MVC)** |  | 119d? | 2025-06-16 A | 2025-11-27 |  | 10% | 106.64d? | 2025-05-05 | 2025-11-27 | 295d | 2024-03-11 | 2025-04-25 | 31602d |  |  | -0 | N/A | N/A | SIT | 6.0 | N/A | Systems Integration Testing (SIT) |  | M10,M11 |  |  |  |  |  | D24D - NF Test Completion Report |
| 1635 | 1.4.2.4.1 | **SIT Functional Testing (non-MVC)** |  | 110d? | 2025-06-16 | 2025-11-14 |  |  |  | 2025-06-16 | 2025-11-14 | 295d | 2024-03-11 | 2025-04-25 | 31602d |  |  |  | N/A | N/A | SIT | 6.0 | N/A | Systems Integration Testing (SIT) |  |  |  |  |  |  |  |  |
| 1636 | 1.4.2.4.1.1 | **SIT Functional Testing Execution (non-MVC)** |  | 95d? | 2025-06-16 | 2025-10-24 |  |  |  | 2025-06-16 | 2025-10-24 | 280d | 2024-03-11 | 2025-04-04 | 31602d |  |  |  | N/A | N/A | SIT | 6.0 | N/A | Systems Integration Testing (SIT) |  | M10 |  |  |  |  |  | D24C - E2E Test Completion Report |
| 1637 | 1.4.2.4.1.1.1 | Test Execution (Cycle 3 Completion and Regression Testing) |  | 95d? | 2025-06-16 | 2025-10-24 | 1546 |  |  | 2025-06-16 | 2025-10-24 | 0d |  |  | 31602d | 0d |  |  |  |  | SIT | 6.0 |  |  |  | 178.33 | Green | GREEN |  |  |  |  |
| 1638 | 1.4.2.4.1.1.2 | SIT Functional Testing End (non-MVC) (incl. confirmation that PPs have submitted their Test Completion Reports to Programme for assurance) | milestone | 0d | 2025-10-24 | 2025-10-24 | 1637FF |  |  | 2025-10-24 | 2025-10-24 | 0d | 2025-04-04 | 2025-04-04 | 31602d | 0d |  |  | SI Test | PP | SIT | 6.0 | Roger Robar | Systems Integration Testing (SIT) | SITAG | 308.71 | Green | GREEN | T3-TE-0052 | T3 | MHHS-ART072 |  |
| 1639 | 1.4.2.4.1.2 | Assurance of PPs Test Completion Reports |  | 5d | 2025-11-03 | 2025-11-07 | 1638FS+5d |  |  | 2025-11-03 | 2025-11-07 | 5d | 2025-04-14 | 2025-04-18 | 31602d | 0d |  |  | SI Test | PP | SIT | 6.0 | Roger Robar | Systems Integration Testing (SIT) |  | 318.33 | Green | GREEN |  |  |  |  |

Notes:
- 1620: 18/12/24 - SITAG approved the extension of Settlement testing and the postponement of NF / Ops data loads and testing, this date has been rebaselined to reflect this.
- 1621: 18/12/24 - SITAG approved the extension of Settlement testing and the postponement of NF / Ops data loads and testing, this date has been rebaselined to reflect this.
- 1622: 18/12/24 - SITAG approved the extension of Settlement testing and the postponement of NF / Ops data loads and testing, this date has been rebaselined to reflect this.
- 1623: 18/12/24 - SITAG approved the extension of Settlement testing and the postponement of NF / Ops data loads and testing, this date has been rebaselined to reflect this.
- 1624: 18/12/24 - SITAG approved the extension of Settlement testing and the postponement of NF / Ops data loads and testing, this date has been rebaselined to reflect this.
- 1625: 18/12/24 - SITAG approved the extension of Settlement testing and the postponement of NF / Ops data loads and testing, this date has been rebaselined to reflect this.
- 1626: 18/12/24 - SITAG approved the extension of Settlement testing and the postponement of NF / Ops data loads and testing, this date has been rebaselined to reflect this.
- 1627: 18/12/24 - SITAG approved the extension of Settlement testing and the postponement of NF / Ops data loads and testing, this date has been rebaselined to reflect this.
- 1628: 18/12/24 - SITAG approved the extension of Settlement testing and the postponement of NF / Ops data loads and testing, this date has been rebaselined to reflect this.
- 1629: 18/12/24 - SITAG approved the extension of Settlement testing and the postponement of NF / Ops data loads and testing, this date has been rebaselined to reflect this.

| ID | WBS | Task | Type | Duration | Start | Finish | Predecessors | Complete | Remaining | Baseline start | Baseline finish | Baseline duration | Baseline 1 start | Baseline 1 finish | Total slack | Free slack | Constraint | Baseline cost | Responsible | Involved | Text9 | Update Version | MHHS Resource Name | MHHS Programme Phase | Task Status | Sched Status | RAG | Artefact ID | Milestone ID | Text29 | Tier | Future RAG |
| --- | --- | --- | --- | --- | --- | --- | --- | --- | --- | --- | --- | --- | --- | --- | --- | --- | --- | --- | --- | --- | --- | --- | --- | --- | --- | --- | --- | --- | --- | --- | --- | --- |
| 1640 | 1.4.2.4.1.3 | **SIT Functional Testing Test Completion Report (non-MVC)** |  | 25d | 2025-10-06 | 2025-11-07 |  |  |  | 2025-10-06 | 2025-11-07 | 25d | 2025-03-17 | 2025-04-18 | 31602d |  |  |  | N/A | N/A | SIT | 6.0 | N/A | Systems Integration Testing (SIT) |  |  |  |  |  |  |  |  |
| 1641 | 1.4.2.4.1.3.1 | Develop document |  | 15d | 2025-10-06 | 2025-10-24 | 1638FF |  |  | 2025-10-06 | 2025-10-24 | 15d | 2025-03-17 | 2025-04-04 | 31607d | 5d |  |  | SI Test |  | SIT | 6.0 | Roger Robar | Systems Integration Testing (SIT) | 290.33 | Green | GREEN |  |  |  |  |  |
| 1642 | 1.4.2.4.1.3.2 | Review & agree document |  | 5d | 2025-11-03 | 2025-11-07 | 1641, 1639FF |  |  | 2025-11-03 | 2025-11-07 | 5d | 2025-04-14 | 2025-04-18 | 31602d | 0d |  |  | SI Test | PP,IPA | SIT | 6.0 | Roger Robar | Systems Integration Testing (SIT) | 318.33 | Green | GREEN |  |  |  |  |  |
| 1643 | 1.4.2.4.1.4 | SIT Functional Testing Test Completion Report (non-MVC) Approved | milestone | 0d | 2025-11-14 | 2025-11-14 | 1642FF+5d |  |  | 2025-11-14 | 2025-11-14 | 0d | 2025-04-25 | 2025-04-25 | 31602d | 0d |  |  | SI Test | PP | SIT | 6.0 | Roger Robar | Systems Integration Testing (SIT) | 329.71 | Green | GREEN | MHHS-ART072 | T3-TE-0055 | SITAG | T3 |  |
| 1644 | 1.4.2.4.2 | **SIT Migration Testing (non-MVC)** |  | 110d | 2025-06-16 A | 2025-11-14 |  | 23% | 85.25d | 2025-05-05 | 2025-10-08 | 230d | 2024-06-10 | 2025-04-25 | 31602d |  |  |  | N/A | N/A | SIT | 6.0 | N/A | Systems Integration Testing (SIT) |  |  |  |  |  |  |  |  |
| 1645 | 1.4.2.4.2.1 | Test Execution (Cycle 3 Completion and Regression Testing) |  | 95d | 2025-06-16 A | 2025-10-24 | 1546 | 28% | 68d | 2025-06-16 | 2025-10-24 | 215d | 2024-06-10 | 2025-04-04 | 31602d | 0d |  |  | SI Test | PP | SIT | 6.0 | Roger Robar | Systems Integration Testing (SIT) |  | Green | GREEN |  |  |  |  | D24E - Migration Test Completion Report |
| 1646 | 1.4.2.4.2.2 | SIT Migration Testing End (non-MVC) (incl. confirmation that PPs have submitted their Test Completion Reports to Programme for assurance) | milestone | 0d | 2025-10-24 | 2025-10-24 | 1645FF |  |  | 2025-10-24 | 2025-10-24 | 0d | 2025-04-04 | 2025-04-04 | 31602d | 0d |  |  | SI Test | PP | SIT | 6.0 | Roger Robar | Systems Integration Testing (SIT) | 308.71 | Green | GREEN | MHHS-ART076 | T3-TE-0051 | SITAG | T3 |  |
| 1647 | 1.4.2.4.2.3 | Assurance of PPs Test Completion Reports |  | 5d | 2025-11-03 | 2025-11-07 | 1646FS+5d |  |  | 2025-11-03 | 2025-11-07 | 5d | 2025-04-14 | 2025-04-18 | 31602d | 0d |  |  | SI Test | PP | SIT | 6.0 | Roger Robar | Systems Integration Testing (SIT) | 318.33 | Green | GREEN |  |  |  |  |  |
| 1648 | 1.4.2.4.2.4 | **SIT Migration Testing Test Completion Report (non-MVC)** |  | 25d | 2025-10-06 | 2025-11-07 |  |  |  | 2025-10-06 | 2025-11-07 | 25d | 2025-03-17 | 2025-04-18 | 31602d |  |  |  | N/A | N/A | SIT | 6.0 | N/A | Systems Integration Testing (SIT) |  |  |  |  |  |  |  |  |
| 1649 | 1.4.2.4.2.4.1 | Develop document |  | 15d | 2025-10-06 | 2025-10-24 | 1646FF |  |  | 2025-10-06 | 2025-10-24 | 15d | 2025-03-17 | 2025-04-04 | 31607d | 5d |  |  | SI Test |  | SIT | 6.0 | Roger Robar | Systems Integration Testing (SIT) | 290.33 | Green | GREEN |  |  |  |  |  |
| 1650 | 1.4.2.4.2.4.2 | Review & agree document |  | 5d | 2025-11-03 | 2025-11-07 | 1649, 1647FF |  |  | 2025-11-03 | 2025-11-07 | 5d | 2025-04-14 | 2025-04-18 | 31602d | 0d |  |  | SI Test | PP,IPA | SIT | 6.0 | Roger Robar | Systems Integration Testing (SIT) | 318.33 | Green | GREEN |  |  |  |  |  |
| 1651 | 1.4.2.4.2.5 | SIT Migration Testing Test Completion Report (non-MVC Approved) | milestone | 0d | 2025-11-14 | 2025-11-14 | 1650FF+5d |  |  | 2025-11-14 | 2025-11-14 | 0d | 2025-04-25 | 2025-04-25 | 31602d | 0d |  |  | SI Test | PP | SIT | 6.0 | Roger Robar | Systems Integration Testing (SIT) | 329.71 | Green | GREEN | MHHS-ART076 | T3-TE-0056 | SITAG | T3 |  |
| 1652 | 1.4.2.4.3 | **SIT non-MVC Test Exit Report** |  | 20d | 2025-10-27 | 2025-11-21 |  |  |  | 2025-10-27 | 2025-11-21 | 20d | 2025-03-17 | 2025-04-11 | 31602d |  |  |  | N/A | N/A | SIT | 6.0 | N/A | Systems Integration Testing (SIT) |  |  |  |  |  |  |  |  |
| 1653 | 1.4.2.4.3.1 | Develop document |  | 15d | 2025-10-27 | 2025-11-14 | 1643FF, 1651FF |  |  | 2025-10-27 | 2025-11-14 | 15d | 2025-03-17 | 2025-04-04 | 31602d | 0d |  |  | SI Test |  | SIT | 6.0 | Roger Robar | Systems Integration Testing (SIT) | 311.33 | Green | GREEN |  |  |  |  |  |
| 1654 | 1.4.2.4.3.2 | Review & agree document |  | 5d | 2025-11-17 | 2025-11-21 | 1653 |  |  | 2025-11-17 | 2025-11-21 | 5d | 2025-04-07 | 2025-04-11 | 31602d | 0d |  |  | SI Test | PP,IPA | SIT | 6.0 | Roger Robar | Systems Integration Testing (SIT) | 332.33 | Green | GREEN |  |  |  |  |  |
| 1655 | 1.4.2.4.4 | SIT non-MVC Complete | milestone | 0d | 2025-11-27 | 2025-11-27 | 1654FS+4d, 1643, 1651 |  |  | 2025-11-27 | 2025-11-27 | 0d | 2025-04-21 | 2025-04-21 | 31602d | 0d |  |  | SI Test | PP | SIT | 6.0 | Roger Robar | Systems Integration Testing (SIT) | 342.71 | Green | GREEN | MHHS-ART081 | T3-TE-0059 | SITAG | T3 |  |
| 1656 | 1.4.3 | **UIT Environment Preparation** |  | 700d? | 2022-10-31 A | 2025-07-04 |  | 48% | 365.49d? | 2022-10-31 | 2025-07-04 | 680d | 2022-10-31 | 2025-06-06 | 32217d |  |  | -0 | N/A | N/A | SIT | 6.0 | N/A | Systems Integration Testing (SIT) |  |  |  |  |  | SITAG |  |  |
| 1657 | 1.4.3.1 | **Test Artefact Development** |  | 556d? | 2023-03-01 A | 2025-04-16 |  | 51% | 270.06d? | 2023-03-01 | 2024-07-18 | 361d | 2023-03-01 | 2023-08-04 | 32274d |  |  | -0 | N/A | N/A | SIT | 6.0 | N/A | Systems Integration Testing (SIT) |  |  |  |  |  | SITAG |  |  |
| 1658 | 1.4.3.1.1 | **E2E Sandbox Guidance** |  | 539d? | 2023-03-01 A | 2025-03-24 |  | 71% | 158.53d? | 2023-03-01 | 2024-07-18 | 361d | 2023-03-01 | 2023-08-04 | 32291d |  |  | -0 | N/A | N/A | SIT | 6.0 | N/A | Systems Integration Testing (SIT) |  |  |  |  |  |  |  |  |
| 1659 | 1.4.3.1.1.1 | Develop document |  | 83d | 2023-03-01 A | 2023-06-23 A |  | 100% |  | 2023-03-01 | 2023-06-23 | 83d | 2023-03-01 | 2023-06-23 |  |  | start no earlier than 2023-03-01 |  | SI Test |  | SIT | 6.0 | Stuart Scott | Systems Integration Testing (SIT) |  | Complete | COMPLETE |  |  |  |  |  |
| 1660 | 1.4.3.1.1.2 | Artefact review (via SITAG) and updates |  | 25d | 2023-06-26 A | 2023-07-28 A | 1659 | 100% |  | 2023-06-26 | 2023-07-28 | 25d | 2023-06-26 | 2023-07-28 |  |  |  |  | SI Test | PP,IPA | SIT | 6.0 | Stuart Scott | Systems Integration Testing (SIT) |  | Complete | COMPLETE |  |  |  |  |  |
| 1661 | 1.4.3.1.1.3 | E2E Sandbox Guidance approved | milestone | 0d | 2024-07-18 A | 2024-07-18 A | 1660FF+5d | 100% |  | 2024-07-18 | 2024-07-18 | 0d | 2023-08-04 | 2023-08-04 |  |  | start no earlier than 2024-07-18 |  | SI Test | PP | SIT | 6.0 | Stuart Scott | Systems Integration Testing (SIT) |  | Complete | COMPLETE | MHHS-ART154 | T3-TE-0067 | QAG | T3 |  |
| 1662 | 1.4.3.1.1.4 | Update E2E Sandbox guidance to reflect CR55 |  | 29d | 2025-01-13 | 2025-02-20 |  |  |  | 2025-01-13 | 2025-02-20 | 0d |  |  | 32291d | 0d | start no earlier than 2025-01-13 |  | SI Test |  | SIT | 6.1 | Stuart Scott |  | 24.33 | Green | GREEN |  |  |  |  |  |
| 1663 | 1.4.3.1.1.5 | Internal SI review |  | 5d | 2025-02-21 | 2025-02-27 | 1662 |  |  | 2025-02-21 | 2025-02-27 | 0d |  |  | 32291d | 0d |  |  | SI Test |  | SIT | 6.1 | Stuart Scott |  | 63.33 | Green | GREEN |  |  |  |  |  |
| 1664 | 1.4.3.1.1.6 | SRO / Code Bodies review |  | 5d | 2025-02-28 | 2025-03-06 | 1663 |  |  | 2025-02-28 | 2025-03-06 | 0d |  |  | 32291d | 0d |  |  | SI Test |  | SIT | 6.1 | Stuart Scott |  | 70.33 | Green | GREEN |  |  |  |  |  |
| 1665 | 1.4.3.1.1.7 | Submit version to QWG |  | 3d | 2025-03-07 | 2025-03-11 | 1664 |  |  | 2025-03-07 | 2025-03-11 | 0d |  |  | 32291d | 0d |  |  | SI Test |  | SIT | 6.1 | Stuart Scott |  | 77.33 | Green | GREEN |  |  |  |  |  |
| 1666 | 1.4.3.1.1.8 | Artefact Approval (via QWG) | milestone | 0d | 2025-03-11 | 2025-03-11 | 1665 |  |  | 2025-03-11 | 2025-03-11 | 0d |  |  | 32291d | 0d |  |  | SI Test |  | SIT | 6.1 | Stuart Scott |  | 81.71 | Green | GREEN |  |  |  |  |  |
| 1667 | 1.4.3.1.1.9 | Final Document updates post QWG review |  | 1d | 2025-03-13 | 2025-03-13 | 1666FS+1d |  |  | 2025-03-13 | 2025-03-13 | 0d |  |  | 32291d | 0d |  |  | SI Test |  | SIT | 6.1 | Stuart Scott |  | 83.33 | Green | GREEN |  |  |  |  |  |
| 1668 | 1.4.3.1.1.10 | Submit final version to QAG |  | 1d? | 2025-03-17 | 2025-03-17 | 1667FS+1d |  |  | 2025-03-17 | 2025-03-17 | 0d |  |  | 32291d | 0d |  |  | SI Test |  | SIT | 6.1 | Stuart Scott |  | 87.33 | Green | GREEN |  |  |  |  |  |
| 1669 | 1.4.3.1.1.11 | E2E Sandbox guidance update approved |  | 1d? | 2025-03-24 | 2025-03-24 | 1668FS+4d |  |  | 2025-03-24 | 2025-03-24 | 0d |  |  | 32291d |  |  |  | SI Test |  | SIT | 6.1 | Stuart Scott |  | 94.33 | Green | GREEN |  |  |  |  |  |

| ID | WBS | Task | Type | Duration | Start | Finish | Predecessors | Complete | Remaining | Baseline start | Baseline finish | Baseline duration | Baseline 1 start | Baseline 1 finish | Total slack | Free slack | Constraint | Baseline cost | Responsible | Involved | Text9 | Update Version | MHHS Resource Name | MHHS Programme Phase | Text29 | Task Status | Sched Status | RAG | Milestone ID | Tier | Artefact ID |
| --- | --- | --- | --- | --- | --- | --- | --- | --- | --- | --- | --- | --- | --- | --- | --- | --- | --- | --- | --- | --- | --- | --- | --- | --- | --- | --- | --- | --- | --- | --- | --- |
| 1670 | 1.4.3.1.2 | **E2E Sandbox Test Data Approach & Plan** |  | 68d | 2025-01-13 | 2025-04-16 |  |  |  | 2023-12-05 | 2024-05-09 | 93d | 2023-03-29 | 2023-08-04 | 32274d |  |  |  | SI Test | N/A | SIT | 6.1 | Stuart Scott | Systems Integration Testing (SIT) | SITAG |  |  |  |  |  |  |
| 1671 | 1.4.3.1.2.1 | Develop document |  | 27d | 2025-01-13 | 2025-02-18 | 1659SS+199d |  |  | 2025-01-13 | 2025-02-18 | 68d | 2023-03-29 | 2023-06-30 | 32274d | 0d | start no earlier than 2025-01-13 |  | SI Test |  | SIT | 5.0 | Stuart Scott | Systems Integration Testing (SIT) |  | 24.33 | Green | GREEN |  |  |  |
| 1672 | 1.4.3.1.2.2 | Internal SI review and updates |  | 5d | 2025-02-19 | 2025-02-25 | 1671 |  |  | 2025-02-19 | 2025-02-25 | 0d |  |  | 32274d | 0d |  |  | SI Test |  | SIT | 6.1 | Stuart Scott |  |  | 61.33 | Green | GREEN |  |  |  |
| 1673 | 1.4.3.1.2.3 | SRO / Code Bodies review |  | 5d | 2025-02-26 | 2025-03-04 | 1672 |  |  | 2025-02-26 | 2025-03-04 | 0d |  |  | 32274d | 0d |  |  | SI Test |  | SIT | 6.1 | Stuart Scott |  |  | 68.33 | Green | GREEN |  |  |  |
| 1674 | 1.4.3.1.2.4 | Submit proposed version to QWG | milestone | 0d | 2025-03-04 | 2025-03-04 | 1673 |  |  | 2025-03-04 | 2025-03-04 | 0d |  |  | 32274d | 0d |  |  | SI Test |  | SIT | 6.1 | Stuart Scott |  |  | 74.71 | Green | GREEN |  |  |  |
| 1675 | 1.4.3.1.2.5 | Discuss document at QWG | milestone | 0d | 2025-03-11 | 2025-03-11 | 1674FS+5d |  |  | 2025-03-11 | 2025-03-11 | 0d |  |  | 32274d | 0d |  |  | SI Test |  | SIT | 6.1 | Stuart Scott |  |  | 81.71 | Green | GREEN |  |  |  |
| 1676 | 1.4.3.1.2.6 | Final updates prior to consultation |  | 4d | 2025-03-12 | 2025-03-17 | 1675 |  |  | 2025-03-12 | 2025-03-17 | 0d |  |  | 32274d | 0d |  |  | SI Test |  | SIT | 6.1 | Stuart Scott |  |  | 82.33 | Green | GREEN |  |  |  |
| 1677 | 1.4.3.1.2.7 | Industry Consultation for E2E Sandbox Test Data Approach and Plan document |  | 10d | 2025-03-18 | 2025-03-31 | 1676 |  |  | 2025-03-18 | 2025-03-31 | 0d |  |  | 32274d | 0d |  |  | SI Test |  | SIT | 6.1 | Stuart Scott |  |  | 88.33 | Green | GREEN |  |  |  |
| 1678 | 1.4.3.1.2.8 | Document updates post Industry Consultation |  | 3d | 2025-04-01 | 2025-04-03 | 1677 |  |  | 2025-04-01 | 2025-04-03 | 0d |  |  | 32274d | 0d | finish no earlier than 2024-04-22 |  | SI Test |  | SIT | 6.1 | Stuart Scott |  |  | 102.33 | Green | GREEN |  |  |  |
| 1679 | 1.4.3.1.2.9 | Submit Proposed Version to QWG |  | 3d | 2025-04-04 | 2025-04-08 | 1678 |  |  | 2025-04-04 | 2025-04-08 | 0d |  |  | 32274d | 0d |  |  | SI Test |  | SIT | 6.1 | Stuart Scott |  |  | 105.33 | Green | GREEN |  |  |  |
| 1680 | 1.4.3.1.2.10 | Artefact Approval (via QWG) | milestone | 0d | 2025-04-08 | 2025-04-08 | 1679 |  |  | 2025-04-08 | 2025-04-08 | 0d |  |  | 32274d | 0d |  |  | SI Test |  | SIT | 6.1 | Stuart Scott |  |  | 109.71 | Green | GREEN |  |  |  |
| 1681 | 1.4.3.1.2.11 | Final Document updates post QWG review | milestone | 0d | 2025-04-09 | 2025-04-09 | 1680FS+1d |  |  | 2025-04-09 | 2025-04-09 | 0d |  |  | 32274d | 0d | start no earlier than 2024-05-01 |  | SI Test |  | SIT | 6.1 | Stuart Scott |  |  | 110.71 | Green | GREEN |  |  |  |
| 1682 | 1.4.3.1.2.12 | Submit final version to QAG | milestone | 0d | 2025-04-10 | 2025-04-10 | 1681FS+1d |  |  | 2025-04-10 | 2025-04-10 | 0d |  |  | 32274d | 0d | start no earlier than 2024-05-02 |  | SI Test |  | SIT | 6.1 | Stuart Scott |  |  | 111.71 | Green | GREEN |  |  |  |
| 1683 | 1.4.3.1.2.13 | E2E Sandbox Test Data Approach and Plan | milestone | 0d | 2025-04-16 | 2025-04-16 | 1682FS+4d |  |  | 2025-04-16 | 2025-04-16 | 0d |  |  | 32274d |  | start no earlier than 2024-05-09 |  | SI Test |  | SIT | 6.1 | Stuart Scott |  | SITAG | 117.71 | Green | GREEN | T3-QU-0124 | T3 |  |
| 1684 | 1.4.3.2 | **UIT Stub Specification and Delivery** |  | 260d | 2023-12-04 A | 2024-11-29 A |  | 100% |  | 2023-12-04 | 2024-10-18 | 190d | 2023-10-27 | 2024-08-23 |  |  |  | -0 | N/A | N/A | SIT | 5.0 | N/A | Systems Integration Testing (SIT) |  |  |  |  |  |  |  |
| 1685 | 1.4.3.2.1 | **Qualification Test Stubs** |  | 260d | 2023-12-04 A | 2024-11-29 A |  | 100% |  | 2023-12-04 | 2024-10-18 | 190d | 2023-10-27 | 2024-08-23 |  |  |  | -0 | N/A | N/A | SIT | 5.16 | N/A | Systems Integration Testing (SIT) |  |  |  |  |  |  |  |
| 1686 | 1.4.3.2.1.1 | Specify |  | 44d | 2023-12-04 A | 2024-02-01 A | 521FS+13d | 100% |  | 2023-12-04 | 2024-02-01 | 44d | 2023-10-27 | 2023-12-29 |  |  |  |  | SI DevOps | Qualification,SRO | SIT | 5.0 | Lewis Hall | Systems Integration Testing (SIT) |  |  | Complete | COMPLETE |  |  |  |
| 1687 | 1.4.3.2.1.2 | Build & Test |  | 141d | 2024-02-02 A | 2024-08-16 A | 1686 | 100% |  | 2024-02-02 | 2024-08-16 | 141d | 2023-12-29 | 2024-05-24 |  |  |  |  | SI DevOps | Qualification,SRO | SIT | 5.23 | Lewis Hall | Systems Integration Testing (SIT) |  |  | Complete | COMPLETE |  |  |  |
| 1688 | 1.4.3.2.1.3 | Prepare for release |  | 75d | 2024-08-19 A | 2024-11-29 A | 1687 | 100% |  | 2024-08-19 | 2024-11-29 | 5d | 2024-07-29 | 2024-08-23 |  |  |  |  | SI DevOps | Qualification,SRO | SIT | 5.0 | Lewis Hall | Systems Integration Testing (SIT) |  |  | Complete | COMPLETE |  |  |  |
| 1689 | 1.4.3.2.1.4 | Non-SIT LDSO Test Harness Released | milestone | 0d | 2024-11-29 A | 2024-11-29 A | 1688 | 100% |  | 2024-11-29 | 2024-11-29 | 0d | 2024-08-23 | 2024-08-23 |  |  |  |  | SI DevOps | Qualification,SRO | SIT | 5.27 | Lewis Hall | Systems Integration Testing (SIT) | QAG |  | Complete | COMPLETE | T3-TE-0035 | T3 | MHHS-ART080 |
| 1690 | 1.4.3.3 | **Environments (UIT)** |  | 700d | 2022-10-31 A | 2025-07-04 |  | 46% | 380.37d | 2022-10-31 | 2025-07-04 | 680d | 2022-10-31 | 2025-06-06 | 32217d |  |  | -0 | N/A | N/A | SIT | 5.0 | N/A | Systems Integration Testing (SIT) |  |  |  |  |  |  |  |
| 1691 | 1.4.3.3.1 | **Central Party (Avanade) Environments (UIT)** |  | 488d | 2022-11-16 A | 2024-09-27 |  | 99% | 0.53d | 2022-11-16 | 2024-09-27 | 493d | 2022-11-16 | 2024-10-04 | 32417d |  |  | -0 | N/A | N/A | SIT | 5.28 | N/A | Systems Integration Testing (SIT) |  |  |  |  |  |  |  |
| 1692 | 1.4.3.3.1.1 | Central Party (Avandae) environment preparation (incl. security certificates and security compliance) |  | 447d | 2022-11-16 A | 2024-08-01 A | 517 | 100% |  | 2022-11-16 | 2024-08-01 | 463d | 2022-11-16 | 2024-08-23 |  |  |  |  | PP | SI Test | SIT | 5.28 | Heath Thomas | Systems Integration Testing (SIT) |  |  | Complete | COMPLETE |  |  |  |
| 1693 | 1.4.3.3.1.2 | Submit self-declaration of environment preparation complete (incl. security certificates and security compliance) to Programme for assurance |  | 447d | 2022-11-16 A | 2024-08-01 A | 1692SS | 100% |  | 2022-11-16 | 2024-08-01 | 463d | 2022-11-16 | 2024-08-23 |  |  |  |  | PP | SI Test | SIT | 5.28 | Heath Thomas | Systems Integration Testing (SIT) |  |  | Complete | COMPLETE |  |  |  |
| 1694 | 1.4.3.3.1.3 | Central Party (Avanade) UIT environment connectivity proving |  | 25d | 2024-08-26 A | 2024-09-27 A | 1706 | 100% |  | 2024-08-26 | 2024-09-27 | 25d | 2024-08-27 | 2024-09-20 |  |  |  |  | PP | SI Test | SIT | 5.28 | Heath Thomas | Systems Integration Testing (SIT) |  |  | Complete | COMPLETE |  |  |  |
| 1695 | 1.4.3.3.1.4 | Deployment of MHHS solution code to UIT environments |  | 2d | 2024-07-29 A | 2024-07-30 A |  | 100% |  | 2024-07-29 | 2024-07-30 | 10d | 2024-09-09 | 2024-09-20 |  |  | start no earlier than 2024-07-29 |  | PP | SI Test | SIT | 5.28 | Heath Thomas | Systems Integration Testing (SIT) |  |  | Complete | COMPLETE |  |  |  |
| 1696 | 1.4.3.3.1.5 | Central Party (Avanade) UIT environment Regression Testing |  | 1d | 2024-07-31 | 2024-07-31 | 1695 |  |  | 2024-07-31 | 2024-07-31 | 10d | 2024-09-23 | 2024-10-04 | 32459d |  |  |  | PP | SI Test | SIT | 5.28 | Heath Thomas | Systems Integration Testing (SIT) |  | -141.67 | Overdue Start | RED |  |  |  |

| ID | WBS | Task | Type | Duration | Start | Finish | Predecessors | Complete | Remaining | Baseline start | Baseline finish | Baseline duration | Baseline 1 start | Baseline 1 finish | Total slack | Free slack | Constraint | Responsible | Involved | Text9 | Update Version | MHHS Resource Name | MHHS Programme Phase | Task Status | Sched Status | RAG | Milestone ID | Text29 | Tier | Artefact ID |
| --- | --- | --- | --- | --- | --- | --- | --- | --- | --- | --- | --- | --- | --- | --- | --- | --- | --- | --- | --- | --- | --- | --- | --- | --- | --- | --- | --- | --- | --- | --- |
| 1697 | 1.4.3.3.2 | **E2E Sandbox Participants (UIT)** |  | 680d | 2022-10-31 | 2025-06-06 |  |  |  | 2022-10-31 | 2025-06-06 | 680d | 2022-10-31 | 2025-06-06 | 0d |  |  | N/A | N/A | SIT | 5.0 | Heath Thomas | Systems Integration Testing (SIT) |  |  |  |  |  |  |  |
| 1698 | 1.4.3.3.2.1 | E2E Sandbox Participants environment preparation (incl. security certificates and security compliance) |  | 660d | 2022-10-31 | 2025-05-09 |  |  |  | 2022-10-31 | 2025-05-09 | 660d | 2022-10-31 | 2025-05-09 | 0d |  | must finish on 2025-05-09 | PP | SI Test | SIT | 5.0 | Heath Thomas | Systems Integration Testing (SIT) | -780.67 | Overdue Start | GREEN |  |  |  |  |
| 1699 | 1.4.3.3.2.2 | Submit self-declaration of environment preparation complete (incl. security certificates and security compliance) to Programme for assurance |  | 660d | 2022-10-31 | 2025-05-09 |  |  |  | 2022-10-31 | 2025-05-09 | 660d | 2022-10-31 | 2025-05-09 | 32237d | 0d |  | PP | SI Test | SIT | 5.0 | Heath Thomas | Systems Integration Testing (SIT) | -780.67 | Overdue Start | GREEN |  |  |  |  |
| 1700 | 1.4.3.3.2.3 | E2E Sandbox Participants UIT environment connectivity proving |  | 20d | 2025-05-12 | 2025-06-06 | 1699 |  |  | 2025-05-12 | 2025-06-06 | 20d | 2025-05-12 | 2025-06-06 | 32237d | 0d |  | PP | SI Test | SIT | 5.0 | Heath Thomas | Systems Integration Testing (SIT) | 143.33 | Green | GREEN |  |  |  |  |
| 1701 | 1.4.3.3.2.4 | Deployment of MHHS solution code to UIT environments |  | 10d | 2025-05-26 | 2025-06-06 | 1700FF |  |  | 2025-05-26 | 2025-06-06 | 10d | 2025-05-26 | 2025-06-06 | 32237d |  |  | PP | SI Test | SIT | 5.0 | Heath Thomas | Systems Integration Testing (SIT) | 157.33 | Green | GREEN |  |  |  |  |
| 1702 | 1.4.3.3.2.5 | Coordinate E2E Sandbox Participants' UIT environment preparation (for E2E Sandbox Testing Start) |  | 463d | 2022-10-31 | 2024-08-07 | 1698SS |  |  | 2022-10-31 | 2024-08-07 | 463d | 2022-10-31 | 2024-08-07 | 32454d |  |  | SI Test | PP | SIT | 5.0 | Heath Thomas | Systems Integration Testing (SIT) | -780.67 | Overdue Start | RED |  |  |  |  |
| 1703 | 1.4.3.3.3 | **SI Environments (UIT)** |  | 688d | 2022-11-16 A | 2025-07-04 |  | 71% | 201.67d | 2022-11-16 | 2025-07-04 | 680d | 2022-10-31 | 2025-06-06 | 32217d |  |  | N/A | N/A | SIT | 5.0 | Heath Thomas | Systems Integration Testing (SIT) |  |  |  |  |  |  |  |
| 1704 | 1.4.3.3.3.1 | Coordinate Central Parties' UIT environment preparation |  | 447d | 2022-11-16 A | 2024-08-01 A | 1692SS | 100% |  | 2022-11-16 | 2024-08-01 | 463d | 2022-11-16 | 2024-08-23 |  |  |  | SI Test | PP | SIT | 5.0 | Heath Thomas | Systems Integration Testing (SIT) |  | Complete | COMPLETE |  |  |  |  |
| 1705 | 1.4.3.3.3.2 | Assure Central Parties' self-declaration of environment preparation complete (incl. security certificates and security compliance) |  | 463d | 2022-11-16 A | 2024-08-23 | 1693SS | 97% | 12d | 2022-11-16 | 2024-08-23 | 463d | 2022-11-16 | 2024-08-23 | 32442d |  |  | SI Test | PP | SIT | 5.0 | Heath Thomas | Systems Integration Testing (SIT) |  | Overdue | RED |  |  |  |  |
| 1706 | 1.4.3.3.3.3 | Central Parties' UIT environments ready to start connectivity proving (incl. certificates and security compliance) | milestone | 0d | 2024-08-23 A | 2024-08-23 A | 1689 | 100% |  | 2024-08-23 | 2024-08-23 | 0d | 2024-08-23 | 2024-08-23 |  |  |  | SI Test | PP | SIT | 5.0 | Heath Thomas | Systems Integration Testing (SIT) |  | Complete | COMPLETE | T3-TE-0044 | QAG | T3 |  |
| 1707 | 1.4.3.3.3.4 | Coordinate Central Parties' UIT environment connectivity proving |  | 26d | 2024-08-26 A | 2024-09-30 A | 1694SS | 100% |  | 2024-08-26 | 2024-09-30 | 19d | 2025-05-12 | 2025-06-05 |  |  |  | SI Test | PP | SIT | 5.0 | Heath Thomas | Systems Integration Testing (SIT) |  | Complete | COMPLETE |  |  |  |  |
| 1708 | 1.4.3.3.3.5 | Coordinate deployment of MHHS solution code to Central Parties' UIT environments |  | 2d | 2024-07-29 A | 2024-07-30 A | 1695SS | 100% |  | 2024-07-29 | 2024-07-30 | 10d | 2025-05-26 | 2025-06-06 |  |  |  | SI Test | PP | SIT | 5.0 | Heath Thomas | Systems Integration Testing (SIT) |  | Complete | COMPLETE |  |  |  |  |
| 1709 | 1.4.3.3.3.6 | Coordinate Central Parties' UIT environment Regression Testing |  | 1d | 2024-07-31 | 2024-07-31 | 1708 |  |  | 2024-07-31 | 2024-07-31 | 10d | 2024-09-23 | 2024-10-04 | 32459d |  |  | SI Test | PP | SIT | 5.0 | Heath Thomas | Systems Integration Testing (SIT) | -141.67 | Overdue Start | RED |  |  |  |  |
| 1710 | 1.4.3.3.3.7 | **Environments (Non-SIT LDSO)** |  | 43d | 2024-08-01 | 2024-09-30 |  |  |  | 2024-08-01 | 2024-09-30 | 115d | 2024-08-06 | 2025-01-13 | 32416d |  |  | N/A | N/A | SIT | 5.28 | Heath Thomas | Qualification |  |  |  |  |  |  |  |
| 1711 | 1.4.3.3.3.7.1 | Coordinate Qualification Participants' environment preparation |  | 17d | 2024-08-01 | 2024-08-23 |  |  |  | 2024-08-01 | 2024-08-23 | 60d | 2024-08-06 | 2024-10-28 | 32442d |  | start no earlier than 2024-08-01 | SI Test | Code Bodies, PP | SIT | 5.28 | Heath Thomas | Qualification | -140.67 | Overdue Start | RED |  |  |  |  |
| 1712 | 1.4.3.3.3.7.2 | Coordinate deployment of MHHS solution code to Qualification Participants' UIT environments |  | 17d | 2024-08-01 | 2024-08-23 |  |  |  | 2024-08-01 | 2024-08-23 | 10d | 2024-10-15 | 2024-10-28 | 32416d | 0d | start no earlier than 2024-08-01 | SI Test | Code Bodies, PP | SIT | 5.28 | Heath Thomas | Qualification | -140.67 | Overdue Start | RED |  |  |  |  |
| 1713 | 1.4.3.3.3.7.3 | Qualification Testing Tranche 1 Participants' UIT environments ready to start connectivity proving (incl. certificates and security compliance) | milestone | 0d | 2024-08-26 | 2024-08-26 | 1712FS+1d |  |  | 2024-08-26 | 2024-08-26 | 0d | 2024-11-04 | 2024-11-04 | 32416d | 0d |  | SI Test | Code Bodies, PP, IPA | SIT | 5.28 | Heath Thomas | Qualification | -115.29 | Overdue Start | RED | T3-TE-0017 | QAG | T3 | MHHS-ART073 |
| 1714 | 1.4.3.3.3.7.4 | **Coordinate Qualification Participants' connectivity proving (Non-SIT LDSO)** |  | 25d | 2024-08-27 | 2024-09-30 |  |  |  | 2024-08-27 | 2024-09-30 | 50d | 2024-11-05 | 2025-01-13 | 32416d |  |  | N/A | N/A | SIT | 5.0 | Heath Thomas | Qualification |  |  |  |  |  |  |  |
| 1715 | 1.4.3.3.3.7.4.1 | Assurance of Qualification Participants' connectivity proving |  | 25d | 2024-08-27 | 2024-09-30 | 1713 |  |  | 2024-08-27 | 2024-09-30 | 50d | 2024-11-05 | 2025-01-13 | 32416d |  |  | SI Test | Code Bodies, PP | SIT | 5.0 | Heath Thomas | Qualification | -114.67 | Overdue Start | RED |  |  |  |  |
| 1716 | 1.4.3.3.3.8 | **Environments (S&A) Wave 1** |  | 41d | 2024-08-01 | 2024-09-26 |  |  |  | 2024-08-01 | 2024-09-26 | 115d | 2024-08-06 | 2025-01-13 |  |  |  | N/A | N/A | SIT | 5.28 | Heath Thomas | Qualification |  |  |  |  |  |  |  |
| 1717 | 1.4.3.3.3.8.1 | Coordinate Qualification Participants' environment preparation |  | 20d | 2024-09-02 | 2024-09-27 |  |  |  | 2024-09-02 | 2024-09-27 | 60d | 2024-08-06 | 2024-10-28 | 32417d |  | start no earlier than 2024-09-02 | SI Test | Code Bodies, PP | SIT | 5.28 | Heath Thomas | Qualification | -108.67 | Overdue Start | RED |  |  |  |  |
| 1718 | 1.4.3.3.3.8.2 | Coordinate deployment of MHHS solution code to Qualification Participants' UIT environments |  | 10d | 2024-10-21 | 2024-11-01 |  |  |  | 2024-10-21 | 2024-11-01 | 10d | 2024-10-15 | 2024-10-28 | 32347d | 0d | start no earlier than 2024-10-21 | SI Test | Code Bodies, PP | SIT | 5.28 | Heath Thomas | Qualification | -59.67 | Overdue Start | GREEN |  |  |  |  |
| 1719 | 1.4.3.3.3.8.3 | Qualification Testing Wave 1 Participants' UIT environments ready to start connectivity proving (incl. certificates and security compliance) |  | 19d | 2024-11-05 | 2024-11-29 | 1718FS+1d |  |  | 2024-11-05 | 2024-11-29 | 0d | 2024-11-04 | 2024-11-04 | 32347d | 0d |  | SI Test | Code Bodies, PP, IPA | SIT | 5.28 | Heath Thomas | Qualification | -44.67 | Green | GREEN |  | QAG | T3 | MHHS-ART073 |
| 1720 | 1.4.3.3.3.8.4 | **Coordinate Qualification Participants' connectivity proving (S&A)** |  | 25d | 2024-12-02 | 2025-01-03 |  |  |  | 2024-12-02 | 2025-01-03 | 50d | 2024-11-05 | 2025-01-13 | 32347d |  |  | N/A | N/A | SIT | 5.0 | Heath Thomas | Qualification |  |  |  |  |  |  |  |
| 1721 | 1.4.3.3.3.8.4.1 | Assurance of Qualification Participants' connectivity proving |  | 25d | 2024-12-02 | 2025-01-03 | 1719 |  |  | 2024-12-02 | 2025-01-03 | 50d | 2024-11-05 | 2025-01-13 | 32347d |  |  | SI Test | Code Bodies, PP | SIT | 5.0 | Heath Thomas | Qualification | -17.67 | Green | GREEN |  |  |  |  |

Notes:
- 1710: 26/11/24 - This is a duplicate, with the more up to date and accurate activity / milestone in S&A plan. QAG to confirm whether this can be removed.
- 1711: 26/11/24 - This is a duplicate, with the more up to date and accurate activity / milestone in S&A plan. QAG to confirm whether this can be removed.
- 1712: 26/11/24 - This is a duplicate, with the more up to date and accurate activity / milestone in S&A plan. QAG to confirm whether this can be removed.
- 1713: 26/11/24 - This is a duplicate, with the more up to date and accurate activity / milestone in S&A plan. QAG to confirm whether this can be removed.
- 1714: 26/11/24 - This is a duplicate, with the more up to date and accurate activity / milestone in S&A plan. QAG to confirm whether this can be removed.
- 1715: 26/11/24 - This is a duplicate, with the more up to date and accurate activity / milestone in S&A plan. QAG to confirm whether this can be removed.
- 1716: 26/11/24 - This is a duplicate, with the more up to date and accurate activity / milestone in S&A plan. QAG to confirm whether this can be removed.
- 1717: 26/11/24 - This is a duplicate, with the more up to date and accurate activity / milestone in S&A plan. QAG to confirm whether this can be removed.
- 1718: 26/11/24 - This is a duplicate, with the more up to date and accurate activity / milestone in S&A plan. QAG to confirm whether this can be removed.
- 1719: 26/11/24 - This is a duplicate, with the more up to date and accurate activity / milestone in S&A plan. QAG to confirm whether this can be removed.
- 1720: 26/11/24 - This is a duplicate, with the more up to date and accurate activity / milestone in S&A plan. QAG to confirm whether this can be removed.
- 1721: 26/11/24 - This is a duplicate, with the more up to date and accurate activity / milestone in S&A plan. QAG to confirm whether this can be removed.

| ID | WBS | Task | Duration | Start | Finish | Predecessors | Baseline start | Baseline finish | Baseline duration | Baseline 1 start | Baseline 1 finish | Total slack | Free slack | Constraint | Baseline cost | Responsible | Involved | Text9 | Update Version | MHHS Resource Name | MHHS Programme Phase | Task Status | Sched Status | RAG | Artefact ID | Text29 | Tier |
| --- | --- | --- | --- | --- | --- | --- | --- | --- | --- | --- | --- | --- | --- | --- | --- | --- | --- | --- | --- | --- | --- | --- | --- | --- | --- | --- | --- |
| 1722 | 1.4.3.3.3.9 | **Environments (S&A) Wave 2** | 139d | 2024-08-27 | 2025-03-07 |  | 2024-08-27 | 2025-03-07 | 115d | 2024-08-06 | 2025-01-13 | 0d |  |  |  | N/A | N/A | SIT | 5.28 | Heath Thomas | Qualification |  |  |  |  |  |  |
| 1723 | 1.4.3.3.3.9.1 | Coordinate Qualification Participants' environment preparation | 20d | 2024-11-18 | 2024-12-13 |  | 2024-11-18 | 2024-12-13 | 60d | 2024-08-06 | 2024-10-28 | 32362d |  | start no earlier than 2024-11-18 |  | SI Test | Code Bodies, PP | SIT | 5.28 | Heath Thomas | Qualification | -31.67 | Green | GREEN |  |  |  |
| 1724 | 1.4.3.3.3.9.2 | Coordinate deployment of MHHS solution code to Qualification Participants' UIT environments | 20d | 2024-12-16 | 2025-01-10 |  | 2024-12-16 | 2025-01-10 | 10d | 2024-10-15 | 2024-10-28 | 32302d | 0d | start no earlier than 2024-12-16 |  | SI Test | Code Bodies, PP | SIT | 5.28 | Heath Thomas | Qualification | -3.67 | Green | GREEN |  |  |  |
| 1725 | 1.4.3.3.3.9.3 | Qualification Testing Wave 2 Participants' UIT environments ready to start connectivity proving (incl. certificates and security compliance) | 15d | 2025-01-13 | 2025-01-31 | 1724 | 2025-01-13 | 2025-01-31 | 0d | 2024-11-04 | 2024-11-04 | 32302d | 0d |  |  | SI Test | Code Bodies, PP, IPA | SIT | 5.28 | Heath Thomas | Qualification | 24.33 | Green | GREEN | MHHS-ART073 | QAG | T3 |
| 1726 | 1.4.3.3.3.9.4 | **Coordinate Qualification Participants' connectivity proving (S&A)** | 25d | 2024-08-27 | 2024-09-30 |  | 2024-08-27 | 2024-09-30 | 50d | 2024-11-05 | 2025-01-13 |  |  |  |  | N/A | N/A | SIT | 5.0 | Heath Thomas | Qualification |  |  |  |  |  |  |
| 1727 | 1.4.3.3.3.9.4.1 | Assurance of Qualification Participants' connectivity proving | 25d | 2025-02-03 | 2025-03-07 | 1725 | 2025-02-03 | 2025-03-07 | 50d | 2024-11-05 | 2025-01-13 | 32302d |  |  |  | SI Test | Code Bodies, PP | SIT | 5.0 | Heath Thomas | Qualification | 45.33 | Green | GREEN |  |  |  |
| 1728 | 1.4.3.3.3.10 | **Environments (S&A) Wave 3** | 80d | 2025-03-17 | 2025-07-04 |  | 2025-03-17 | 2025-07-04 | 115d | 2024-08-06 | 2025-01-13 | 32217d |  |  |  | N/A | N/A | SIT | 5.28 | Heath Thomas | Qualification |  |  |  |  |  |  |
| 1729 | 1.4.3.3.3.10.1 | Coordinate Qualification Participants' environment preparation | 30d | 2025-03-17 | 2025-04-25 |  | 2025-03-17 | 2025-04-25 | 60d | 2024-08-06 | 2024-10-28 | 32267d |  | start no earlier than 2025-03-17 |  | SI Test | Code Bodies, PP | SIT | 5.28 | Heath Thomas | Qualification | 87.33 | Green | GREEN |  |  |  |
| 1730 | 1.4.3.3.3.10.2 | Coordinate deployment of MHHS solution code to Qualification Participants' UIT environments | 10d | 2025-04-28 | 2025-05-09 |  | 2025-04-28 | 2025-05-09 | 10d | 2024-10-15 | 2024-10-28 | 32217d | 0d | start no earlier than 2025-04-28 |  | SI Test | Code Bodies, PP | SIT | 5.28 | Heath Thomas | Qualification | 129.33 | Green | GREEN |  |  |  |
| 1731 | 1.4.3.3.3.10.3 | Qualification Testing Wave 3 Participants' UIT environments ready to start connectivity proving (incl. certificates and security compliance) | 14d | 2025-05-13 | 2025-05-30 | 1730FS+1d | 2025-05-13 | 2025-05-30 | 0d | 2024-11-04 | 2024-11-04 | 32217d | 0d |  |  | SI Test | Code Bodies, PP, IPA | SIT | 5.28 | Heath Thomas | Qualification | 144.33 | Green | GREEN | MHHS-ART073 | QAG | T3 |
| 1732 | 1.4.3.3.3.10.4 | **Coordinate Qualification Participants' connectivity proving (S&A)** | 25d | 2025-06-02 | 2025-07-04 |  | 2025-06-02 | 2025-07-04 | 50d | 2024-11-05 | 2025-01-13 | 32217d |  |  |  | N/A | N/A | SIT | 5.0 | Heath Thomas | Qualification |  |  |  |  |  |  |
| 1733 | 1.4.3.3.3.10.4.1 | Assurance of Qualification Participants' connectivity proving | 25d | 2025-06-02 | 2025-07-04 | 1731 | 2025-06-02 | 2025-07-04 | 50d | 2024-11-05 | 2025-01-13 | 32217d |  |  |  | SI Test | Code Bodies, PP | SIT | 5.0 | Heath Thomas | Qualification | 164.33 | Green | GREEN |  |  |  |
| 1734 | 1.4.3.3.3.11 | **Environments (S&A) Wave 4** | 80d | 2025-03-17 | 2025-07-04 |  | 2025-03-17 | 2025-07-04 | 115d | 2024-08-06 | 2025-01-13 | 55d |  |  |  | N/A | N/A | SIT | 5.28 | Heath Thomas | Qualification |  |  |  |  |  |  |
| 1735 | 1.4.3.3.3.11.1 | Coordinate Qualification Participants' environment preparation | 30d | 2025-03-17 | 2025-04-25 |  | 2025-03-17 | 2025-04-25 | 60d | 2024-08-06 | 2024-10-28 | 32267d |  | finish no earlier than 2025-04-25 |  | SI Test | Code Bodies, PP | SIT | 5.28 | Heath Thomas | Qualification | 87.33 | Green | GREEN |  |  |  |
| 1736 | 1.4.3.3.3.11.2 | Coordinate deployment of MHHS solution code to Qualification Participants' UIT environments | 10d | 2025-04-28 | 2025-05-09 |  | 2025-04-28 | 2025-05-09 | 10d | 2024-10-15 | 2024-10-28 | 32217d | 0d | finish no earlier than 2025-05-09 |  | SI Test | Code Bodies, PP | SIT | 5.28 | Heath Thomas | Qualification | 129.33 | Green | GREEN |  |  |  |
| 1737 | 1.4.3.3.3.11.3 | Qualification Testing Wave 4 Participants' UIT environments ready to start connectivity proving (incl. certificates and security compliance) | 14d | 2025-05-13 | 2025-05-30 | 1736FS+1d | 2025-05-13 | 2025-05-30 | 0d | 2024-11-04 | 2024-11-04 | 32217d | 0d | finish no earlier than 2025-05-30 |  | SI Test | Code Bodies, PP, IPA | SIT | 5.28 | Heath Thomas | Qualification | 144.33 | Green | GREEN | MHHS-ART073 | QAG | T3 |
| 1738 | 1.4.3.3.3.11.4 | **Coordinate Qualification Participants' connectivity proving (S&A)** | 25d | 2025-06-02 | 2025-07-04 |  | 2025-06-02 | 2025-07-04 | 50d | 2024-11-05 | 2025-01-13 |  |  |  |  | N/A | N/A | SIT | 5.0 | N/A | Qualification |  |  |  |  |  |  |
| 1739 | 1.4.3.3.3.11.4.1 | Assurance of Qualification Participants' connectivity proving | 25d | 2025-06-02 | 2025-07-04 | 1737 | 2025-06-02 | 2025-07-04 | 50d | 2024-11-05 | 2025-01-13 | 32217d |  | start no earlier than 2025-06-02 |  | SI Test | Code Bodies, PP | SIT | 5.0 |  | Qualification | 164.33 | Green | GREEN |  |  |  |
| 1740 | 1.4.3.4 | **Test Data** | 30d | 2024-08-26 | 2024-10-04 |  | 2024-08-26 | 2024-10-04 | 30d | 2024-08-26 | 2024-10-04 | 32392d |  |  | -0 | N/A | N/A | SIT | 5.0 | N/A | Systems Integration Testing (SIT) |  |  |  |  |  |  |
| 1741 | 1.4.3.4.1 | **Central Parties (for E2E Sandbox & Qualification)** | 30d | 2024-08-26 | 2024-10-04 |  | 2024-08-26 | 2024-10-04 | 30d | 2024-08-26 | 2024-10-04 | 32392d |  |  |  | N/A | N/A | SIT | 5.0 | N/A | Systems Integration Testing (SIT) |  |  |  |  |  |  |
| 1742 | 1.4.3.4.1.1 | Central Parties' UIT environment test data loading & verification (& data cleansing, if required) | 30d | 2024-08-26 | 2024-10-04 |  | 2024-08-26 | 2024-10-04 | 30d | 2024-08-26 | 2024-10-04 | 32392d | 0d | start no earlier than 2024-08-26 |  | PP | SI Test | SIT | 5.0 | Richard Puddephat | Systems Integration Testing (SIT) | -115.67 | Overdue Start | RED |  |  |  |
| 1743 | 1.4.3.4.1.2 | Submit self-declaration to Programme to confirm loading & verification of test data | 30d | 2024-08-26 | 2024-10-04 | 1742SS | 2024-08-26 | 2024-10-04 | 30d | 2024-08-26 | 2024-10-04 | 32392d | 0d |  |  | PP | SI Test | SIT | 5.0 | Richard Puddephat | Systems Integration Testing (SIT) | -115.67 | Overdue Start | RED |  |  |  |
| 1744 | 1.4.3.4.2 | **E2E Sandbox Participants** | 30d | 2024-08-26 | 2024-10-04 |  | 2024-08-26 | 2024-10-04 | 30d | 2024-08-26 | 2024-10-04 | 32412d |  |  | -0 | N/A | N/A | SIT | 5.0 | Richard Puddephat | Systems Integration Testing (SIT) |  |  |  |  |  |  |
| 1745 | 1.4.3.4.2.1 | UIT environment test data loading and verification (and data cleansing, if required) (for E2E Sandbox Testing Start) | 30d | 2024-08-26 | 2024-10-04 | 1742FF | 2024-08-26 | 2024-10-04 | 30d | 2024-08-26 | 2024-10-04 | 32412d | 0d |  |  | PP | SI Test | SIT | 5.0 | Richard Puddephat | Systems Integration Testing (SIT) | -115.67 | Overdue Start | RED |  |  |  |

Notes:
- 1722: 26/11/24 - This is a duplicate, with the more up to date and accurate activity / milestone in S&A plan. QAG to confirm whether this can be removed.
- 1723: 26/11/24 - This is a duplicate, with the more up to date and accurate activity / milestone in S&A plan. QAG to confirm whether this can be removed.
- 1724: 26/11/24 - This is a duplicate, with the more up to date and accurate activity / milestone in S&A plan. QAG to confirm whether this can be removed.
- 1725: 26/11/24 - This is a duplicate, with the more up to date and accurate activity / milestone in S&A plan. QAG to confirm whether this can be removed.
- 1726: 26/11/24 - This is a duplicate, with the more up to date and accurate activity / milestone in S&A plan. QAG to confirm whether this can be removed.
- 1727: 26/11/24 - This is a duplicate, with the more up to date and accurate activity / milestone in S&A plan. QAG to confirm whether this can be removed.
- 1728: 26/11/24 - This is a duplicate, with the more up to date and accurate activity / milestone in S&A plan. QAG to confirm whether this can be removed.
- 1729: 26/11/24 - This is a duplicate, with the more up to date and accurate activity / milestone in S&A plan. QAG to confirm whether this can be removed.
- 1730: 26/11/24 - This is a duplicate, with the more up to date and accurate activity / milestone in S&A plan. QAG to confirm whether this can be removed.
- 1731: 26/11/24 - This is a duplicate, with the more up to date and accurate activity / milestone in S&A plan. QAG to confirm whether this can be removed.
- 1732: 26/11/24 - This is a duplicate, with the more up to date and accurate activity / milestone in S&A plan. QAG to confirm whether this can be removed.
- 1733: 26/11/24 - This is a duplicate, with the more up to date and accurate activity / milestone in S&A plan. QAG to confirm whether this can be removed.
- 1734: 26/11/24 - This is a duplicate, with the more up to date and accurate activity / milestone in S&A plan. QAG to confirm whether this can be removed.
- 1735: 26/11/24 - This is a duplicate, with the more up to date and accurate activity / milestone in S&A plan. QAG to confirm whether this can be removed.
- 1736: 26/11/24 - This is a duplicate, with the more up to date and accurate activity / milestone in S&A plan. QAG to confirm whether this can be removed.
- 1737: 26/11/24 - This is a duplicate, with the more up to date and accurate activity / milestone in S&A plan. QAG to confirm whether this can be removed.
- 1738: 26/11/24 - This is a duplicate, with the more up to date and accurate activity / milestone in S&A plan. QAG to confirm whether this can be removed.
- 1739: 26/11/24 - This is a duplicate, with the more up to date and accurate activity / milestone in S&A plan. QAG to confirm whether this can be removed.
- 1740: 18/12/24 - Programme is working on updating these dates over the coming weeks.
- 1741: 18/12/24 - Programme is working on updating these dates over the coming weeks.
- 1742: 18/12/24 - Programme is working on updating these dates over the coming weeks.
- 1743: 18/12/24 - Programme is working on updating these dates over the coming weeks.
- 1744: 18/12/24 - Programme is working on updating these dates over the coming weeks.
- 1745: 18/12/24 - Programme is working on updating these dates over the coming weeks.

| ID | WBS | Task | Type | Duration | Start | Finish | Predecessors | Complete | Remaining | Baseline start | Baseline finish | Baseline duration | Baseline 1 start | Baseline 1 finish | Total slack | Free slack | Constraint | Baseline cost | Responsible | Involved | Text9 | Update Version | MHHS Resource Name | MHHS Programme Phase | Task Status | Sched Status | RAG | Artefact ID | Milestone ID | Text29 | Tier |
| --- | --- | --- | --- | --- | --- | --- | --- | --- | --- | --- | --- | --- | --- | --- | --- | --- | --- | --- | --- | --- | --- | --- | --- | --- | --- | --- | --- | --- | --- | --- | --- |
| 1746 | 1.4.3.4.3 | **SI Test Data** |  | 30d | 2024-08-26 | 2024-10-04 |  |  |  | 2024-08-26 | 2024-10-04 | 30d | 2024-08-26 | 2024-10-04 | 32412d |  |  |  | N/A | N/A | SIT | 5.0 | Richard Puddephat | Systems Integration Testing (SIT) |  |  |  |  |  |  |  |
| 1747 | 1.4.3.4.3.1 | Coordinate Central Parties' UIT environment test data loading and verification (and data cleansing, if required) |  | 30d | 2024-08-26 | 2024-10-04 | 1742SS |  |  | 2024-08-26 | 2024-10-04 | 30d | 2024-08-26 | 2024-10-04 | 32412d |  |  |  | SI Test | PP | SIT | 5.0 | Richard Puddephat | Systems Integration Testing (SIT) | -115.67 | Overdue Start | RED |  |  |  |  |
| 1748 | 1.4.3.4.3.2 | Assure evidence of Central Parties' UIT environment test data load and verification |  | 30d | 2024-08-26 | 2024-10-04 | 1743SS |  |  | 2024-08-26 | 2024-10-04 | 30d | 2024-08-26 | 2024-10-04 | 32412d |  |  |  | SI Test | PP | SIT | 5.0 | Richard Puddephat | Systems Integration Testing (SIT) | -115.67 | Overdue Start | RED |  |  |  |  |
| 1749 | 1.4.3.4.3.3 | Coordinate E2E Sandbox Participants' UIT environment test data loading and verification (and data cleansing, if required) (for E2E Sandbox Testing Start) |  | 30d | 2024-08-26 | 2024-10-04 | 1745SS |  |  | 2024-08-26 | 2024-10-04 | 30d | 2024-08-26 | 2024-10-04 | 32412d |  |  |  | SI Test | PP | SIT | 5.0 | Richard Puddephat | Systems Integration Testing (SIT) | -115.67 | Overdue Start | RED |  |  |  |  |
| 1750 | 1.4.3.5 | **Other Preparation** |  | 496d | 2022-10-31 A | 2024-09-23 |  | 59% | 201.3d | 2022-10-31 | 2024-09-23 | 484d | 2022-11-16 | 2024-09-23 | 32421d |  |  |  | N/A | N/A | SIT | 5.0 | N/A | Systems Integration Testing (SIT) |  |  |  |  |  |  |  |
| 1751 | 1.4.3.5.1 | **SI Other Preparation** |  | 66d | 2022-10-31 | 2023-01-30 |  |  |  | 2022-10-31 | 2023-01-30 | 66d | 2024-05-02 | 2024-08-01 | 32851d |  |  |  | N/A | N/A | SIT | 5.0 | N/A | Systems Integration Testing (SIT) |  |  |  |  |  |  |  |
| 1752 | 1.4.3.5.1.1 | Onboarding of UIT E2E Sandbox Participants to Test Management Tool for E2E Sandbox Testing Start (onboarding of participants will be ongoing hereafter) |  | 66d | 2022-10-31 | 2023-01-30 |  |  |  | 2022-10-31 | 2023-01-30 | 66d | 2024-05-02 | 2024-08-01 | 32851d | 393d |  |  | SI Test | PP | SIT | 5.0 | Stuart Scott | Systems Integration Testing (SIT) | -780.67 | Overdue Start | RED |  |  |  |  |
| 1753 | 1.4.3.5.2 | **Other Preparation (for Central Parties & E2E Sandbox Participants)** |  | 484d | 2022-11-16 A | 2024-09-23 |  | 67% | 161.92d | 2022-11-16 | 2024-09-23 | 484d | 2022-11-16 | 2024-09-23 | 32421d |  |  |  | N/A | N/A | SIT | 5.0 | N/A | Systems Integration Testing (SIT) |  |  |  |  |  |  |  |
| 1754 | 1.4.3.5.2.1 | Test Management Tool onboarding for E2E Sandbox Testing Start (onboarding will be ongoing hereafter) |  | 66d | 2024-05-02 | 2024-08-01 | 1752SS |  |  | 2024-05-02 | 2024-08-01 | 66d | 2024-05-02 | 2024-08-01 | 32458d |  | start no earlier than 2024-05-02 |  | PP | SI Test | SIT | 5.0 | Stuart Scott | Systems Integration Testing (SIT) | -231.67 | Overdue Start | RED |  |  |  |  |
| 1755 | 1.4.3.5.2.2 | Other Preparation (incl. test execution planning) |  | 484d | 2022-11-16 A | 2024-09-23 | 1692SS, 1698SS | 76% | 118d | 2022-11-16 | 2024-09-23 | 484d | 2022-11-16 | 2024-09-23 | 32421d |  |  |  | PP | SI Test | SIT | 5.0 | Stuart Scott | Systems Integration Testing (SIT) |  | Overdue | RED |  |  |  |  |
| 1756 | 1.4.3.6 | **UIT E2E Sandbox Test Readiness Report** |  | 114d | 2024-08-26 | 2025-01-31 |  |  |  | 2024-08-26 | 2025-01-31 | 114d | 2024-08-26 | 2024-10-25 | 32323d |  |  | -0 | N/A | N/A | SIT | 5.0 | N/A | Systems Integration Testing (SIT) |  |  |  |  |  |  |  |
| 1757 | 1.4.3.6.1 | **Central Parties E2E Sandbox Test Readiness Report** |  | 30d | 2024-08-26 | 2024-10-04 |  |  |  | 2024-08-26 | 2024-10-04 | 30d | 2024-08-26 | 2024-10-04 | 32392d |  |  |  | N/A | N/A | SIT | 5.0 | N/A | Systems Integration Testing (SIT) |  |  |  |  |  |  |  |
| 1758 | 1.4.3.6.1.1 | Develop draft Test Readiness Report and submit to Programme for assurance |  | 20d | 2024-08-26 | 2024-09-20 | 1743FF-10d |  |  | 2024-08-26 | 2024-09-20 | 20d | 2024-08-26 | 2024-09-20 | 32392d | 0d |  |  | PP | SI Test | SIT | 5.0 | Stuart Scott | Systems Integration Testing (SIT) | -115.67 | Overdue Start | RED |  |  |  |  |
| 1759 | 1.4.3.6.1.2 | Finalise Test Readiness Report and submit to Programme for assurance |  | 10d | 2024-09-23 | 2024-10-04 | 1743FF |  |  | 2024-09-23 | 2024-10-04 | 10d | 2024-09-23 | 2024-10-04 | 32392d | 0d |  |  | PP | SI Test | SIT | 5.0 | Stuart Scott | Systems Integration Testing (SIT) | -87.67 | Overdue Start | RED |  |  |  |  |
| 1760 | 1.4.3.6.2 | **SI E2E Sandbox Test Readiness Report** |  | 40d | 2024-08-26 | 2024-10-18 |  |  |  | 2024-08-26 | 2024-10-18 | 40d | 2024-08-26 | 2024-10-18 | 32392d |  |  |  | N/A | N/A | SIT | 5.0 | N/A | Systems Integration Testing (SIT) |  |  |  |  |  |  |  |
| 1761 | 1.4.3.6.2.1 | Assure Central Parties' E2E Sandbox Test Readiness Reports |  | 35d | 2024-08-26 | 2024-10-11 | 1758SS, 1759FF+5d |  |  | 2024-08-26 | 2024-10-11 | 35d | 2024-08-26 | 2024-10-11 | 32392d | 0d |  |  | SI Test | PP | SIT | 5.0 | Stuart Scott | Systems Integration Testing (SIT) | -115.67 | Overdue Start | RED |  |  |  |  |
| 1762 | 1.4.3.6.2.2 | Develop Overarching E2E Sandbox Test Readiness Report |  | 20d | 2024-09-16 | 2024-10-11 | 1761FF |  |  | 2024-09-16 | 2024-10-11 | 20d | 2024-09-16 | 2024-10-11 | 32392d | 0d |  |  | SI Test |  | SIT | 5.0 | Stuart Scott | Systems Integration Testing (SIT) | -94.67 | Overdue Start | RED |  |  |  |  |
| 1763 | 1.4.3.6.2.3 | Artefact review (via SITAG) and updates |  | 5d | 2024-10-14 | 2024-10-18 | 1762 |  |  | 2024-10-14 | 2024-10-18 | 5d | 2024-10-14 | 2024-10-18 | 32392d | 69d |  |  | SI Test | PP,IPA | SIT | 5.0 | Stuart Scott | Systems Integration Testing (SIT) | -66.67 | Overdue Start | RED |  |  |  |  |
| 1764 | 1.4.3.6.3 | UIT E2E Sandbox Preparation Complete | milestone | 0d | 2025-01-31 | 2025-01-31 | 1763FS+5d |  |  | 2025-01-31 | 2025-01-31 | 0d | 2024-10-25 | 2024-10-25 | 32323d | 131d | start no earlier than 2025-01-31 |  | SI Test | PP | SIT | 5.28 | Stuart Scott | Systems Integration Testing (SIT) | 42.33 | Green | GREEN | MHHS-ART154 MHHS-ART147 | T3-TE-0048 | QAG | T3 |
| 1765 | 1.4.4 | **Sandbox Testing Execution (UIT)** |  | 260d | 2025-09-01 | 2026-08-28 |  |  |  | 2025-02-07 | 2026-04-24 | 316d | 2024-11-04 | 2026-01-19 | 31917d |  |  | -0 | N/A | N/A | SIT | 6.15 | N/A | Systems Integration Testing (SIT) |  |  |  |  |  |  |  |
| 1766 | 1.4.4.1 | Sandbox Testing Start (UIT) | milestone | 0d | 2025-09-01 | 2025-09-01 | 1633, 2204FS+5d, 1764 |  |  | 2025-09-01 | 2025-09-01 | 0d | 2024-11-04 | 2024-11-04 | 32176d | 0d | start no earlier than 2025-02-10 |  | SI Test | PP | SIT | 6.15 | Stuart Scott | Systems Integration Testing (SIT) | 255.71 | Green | GREEN | MHHS-ART018 MHHS-ART154 MHHS-ART147 | T3-TE-0049 | QAG | T3 |
| 1767 | 1.4.4.2 | Sandbox Testing Execution (UIT) |  | 260d | 2025-09-01 | 2026-08-28 | 1766SS-1d |  |  | 2025-09-01 | 2026-08-28 | 316d | 2024-11-04 | 2026-01-19 | 31917d | 0d | start no earlier than 2024-11-04 |  | PP | SI Test | SIT | 6.15 | Stuart Scott | Systems Integration Testing (SIT) | 255.33 | Green | GREEN |  |  |  |  |
| 1768 | 1.4.4.3 | Sandbox Testing End (UIT) | milestone | 0d | 2026-08-28 | 2026-08-28 | 1767 |  |  | 2026-08-28 | 2026-08-28 |  |  |  | 31917d |  |  |  |  |  |  | 6.15 |  |  | 616.71 | Green | GREEN |  | T3-TE-XXXX |  |  |
| 1769 | 1.4.5 | **SIT PPs Early Sandbox Testing Execution (SIT-A)** |  | 56d | 2025-08-08 | 2025-10-24 |  |  |  | 2025-02-07 | 2026-04-24 | 316d | 2024-11-04 | 2026-01-19 | 32137d |  |  | -0 | N/A | N/A | SIT | 6.15 | N/A | Systems Integration Testing (SIT) |  |  |  |  |  |  |  |
| 1770 | 1.4.5.1 | SIT PPs E2E Sandbox Testing Start | milestone | 0d | 2025-08-08 | 2025-08-08 | 1764FS+5d, 1551 |  |  | 2025-08-08 | 2025-08-08 | 0d | 2024-11-04 | 2024-11-04 | 32192d | 0d | start no earlier than 2025-02-10 |  | SI Test | PP | SIT | 6.15 | Stuart Scott | Systems Integration Testing (SIT) | 231.71 | Green | GREEN | MHHS-ART018 MHHS-ART154 MHHS-ART147 | T3-TE-0049 | QAG | T3 |
| 1771 | 1.4.5.2 | SIT PPs E2E Sandbox Testing Execution |  | 56d | 2025-08-08 | 2025-10-24 | 1770SS-1d |  |  | 2025-02-07 | 2026-04-24 | 316d | 2024-11-04 | 2026-01-19 | 32137d |  | start no earlier than 2024-11-04 |  | PP | SI Test | SIT | 6.15 | Stuart Scott | Systems Integration Testing (SIT) | 231.33 | Green | GREEN |  |  |  |  |

Notes:
- 1746: 18/12/24 - Programme is working on updating these dates over the coming weeks.
- 1747: 18/12/24 - Programme is working on updating these dates over the coming weeks.
- 1748: 18/12/24 - Programme is working on updating these dates over the coming weeks.
- 1749: 18/12/24 - Programme is working on updating these dates over the coming weeks.
- 1750: 18/12/24 - Programme is working on updating these dates over the coming weeks.
- 1751: 18/12/24 - Programme is working on updating these dates over the coming weeks.
- 1752: 18/12/24 - Programme is working on updating these dates over the coming weeks.
- 1753: 18/12/24 - Programme is working on updating these dates over the coming weeks.
- 1754: 18/12/24 - Programme is working on updating these dates over the coming weeks.
- 1755: 18/12/24 - Programme is working on updating these dates over the coming weeks.
- 1756: 18/12/24 - Programme is working on updating these dates over the coming weeks.
- 1757: 18/12/24 - Programme is working on updating these dates over the coming weeks.
- 1758: 18/12/24 - Programme is working on updating these dates over the coming weeks.
- 1759: 18/12/24 - Programme is working on updating these dates over the coming weeks.
- 1760: 18/12/24 - Programme is working on updating these dates over the coming weeks.
- 1761: 18/12/24 - Programme is working on updating these dates over the coming weeks.
- 1762: 18/12/24 - Programme is working on updating these dates over the coming weeks.
- 1763: 18/12/24 - Programme is working on updating these dates over the coming weeks.
- 1764: 18/12/24 - Programme is working on updating these dates over the coming weeks.
- 1765: 18/12/24 - Programme has added in new activity to represent Sandbox Testing Execution. Programme is due to expand this over the coming weeks.
- 1766: 18/12/24 - Programme has added in new activity to represent Sandbox Testing Execution. Programme is due to expand this over the coming weeks.
- 1767: 18/12/24 - Programme has added in new activity to represent Sandbox Testing Execution. Programme is due to expand this over the coming weeks.
- 1768: 18/12/24 - Programme has added in new activity to represent Sandbox Testing Execution. Programme is due to expand this over the coming weeks.
- 1769: 18/12/24 - Programme has updated this activity to relfect CR055 recalibration. Programme is due to expand this over the coming weeks.
- 1770: 18/12/24 - Programme has updated this activity to relfect CR055 recalibration. Programme is due to expand this over the coming weeks.
- 1771: 18/12/24 - Programme has updated this activity to relfect CR055 recalibration. Programme is due to expand this over the coming weeks.

| ID | WBS | Task | Type | Duration | Start | Finish | Predecessors | Complete | Remaining | Baseline start | Baseline finish | Baseline duration | Baseline 1 start | Baseline 1 finish | Total slack | Free slack | Constraint | Baseline cost | Text9 | Task Status | Update Version | Sched Status | Text29 | Responsible | RAG | Milestone ID | Tier | Involved | Future RAG | MHHS Resource Name | MHHS Programme Phase |
| --- | --- | --- | --- | --- | --- | --- | --- | --- | --- | --- | --- | --- | --- | --- | --- | --- | --- | --- | --- | --- | --- | --- | --- | --- | --- | --- | --- | --- | --- | --- | --- |
| 1772 | 1.4.6 | **System Integration Testing - Tier 1 Milestones** |  | 214d? | 2025-02-28 | 2025-12-24 |  |  |  | 2025-02-28 | 2025-12-24 | 0d |  |  | 31727d |  |  |  | SIT | -685.67 | 6.15 | Overdue Start | SITAG |  |  |  |  |  |  |  |  |
| 1773 | 1.4.6.1 | M10 Checkpoint |  | 1d? | 2025-02-28 | 2025-02-28 | 1774FS-149d |  |  | 2025-02-28 | 2025-02-28 | 0d |  |  | 32307d |  |  |  | SIT | 70.33 | 6.1 | Green | SITAG | SI Test | GREEN | T3-MI-0040 | T3 |  |  |  |  |
| 1774 | 1.4.6.2 | Central systems ready for migrating MPANs (M10) | milestone | 0d | 2025-09-24 | 2025-09-24 | 1633FS+20d, 2898, 2653FS+2d, 2650, 2665, 2632, 2636 |  |  | 2025-09-24 | 2025-09-24 | 0d | 2025-03-07 | 2025-03-07 | 31578d | 0d |  |  | SIT | 278.71 | 6.1 | Green | PSG | CPT | GREEN | T1-MI-1000 | T1 | CPT | Central systems ready for migrating MPANs | CPT | Migration |
| 1775 | 1.4.6.3 | Central systems ready for migrating MPANs (M10*) - Late Exit | milestone | 0d | 2025-12-24 | 2025-12-24 | 1774FS+65d |  |  | 2025-12-24 | 2025-12-24 | 0d | 2025-06-06 | 2025-06-06 | 32094d |  |  |  | SIT | 369.71 | 6.1 | Green | PSG | CPT | GREEN | T2-MI-1500 | T1 | CPT | Central systems ready for migrating MPANs | CPT | Migration |
| 1776 | 1.4.7 | **External Programme Dependency Management** |  | 174d | 2022-10-31 A | 2023-06-30 A |  | 100% |  | 2022-10-31 | 2023-06-30 | 174d | 2022-10-31 | 2023-06-30 |  |  |  |  | SIT |  | 5.0 |  |  | N/A |  |  |  | N/A |  | N/A | Systems Integration Testing (SIT) |
| 1777 | 1.4.7.1 | **BSC CP1558** |  | 173d | 2022-10-31 A | 2023-06-29 A |  | 100% |  | 2022-10-31 | 2023-06-29 | 173d | 2022-10-31 | 2023-06-29 |  |  |  |  | SIT |  | 5.0 |  |  | N/A |  |  |  | N/A |  | N/A | Systems Integration Testing (SIT) |
| 1778 | 1.4.7.1.1 | Monitor progress to implementation date |  | 173d | 2022-10-31 A | 2023-06-28 A |  | 100% |  | 2022-10-31 | 2023-06-28 | 173d | 2022-10-31 | 2023-06-28 |  |  |  |  | SIT |  | 5.0 | Complete |  | CPT | COMPLETE |  |  | Code Bodies |  | Andrew Margan | Systems Integration Testing (SIT) |
| 1779 | 1.4.7.1.2 | BSC CP1558 Implementation Date | milestone | 0d | 2023-06-29 A | 2023-06-29 A | 1778 | 100% |  | 2023-06-29 | 2023-06-29 | 0d | 2023-06-29 | 2023-06-29 |  |  | must start on 2023-06-29 |  | SIT |  | 5.0 | Complete |  | Code Bodies | COMPLETE |  |  |  |  | Andrew Margan | Systems Integration Testing (SIT) |
| 1780 | 1.4.7.2 | **REC CP R0032** |  | 174d | 2022-10-31 A | 2023-06-30 A |  | 100% |  | 2022-10-31 | 2023-06-30 | 174d | 2022-10-31 | 2023-06-30 |  |  |  |  | SIT |  | 5.0 |  |  | N/A |  |  |  | N/A |  | N/A | Systems Integration Testing (SIT) |
| 1781 | 1.4.7.2.1 | Monitor progress to implementation date |  | 174d | 2022-10-31 A | 2023-06-29 A |  | 100% |  | 2022-10-31 | 2023-06-29 | 174d | 2022-10-31 | 2023-06-29 |  |  |  |  | SIT |  | 5.0 | Complete |  | CPT | COMPLETE |  |  | Code Bodies |  | Andrew Margan | Systems Integration Testing (SIT) |
| 1782 | 1.4.7.2.2 | REC CP R0032 Implementation Date | milestone | 0d | 2023-06-30 A | 2023-06-30 A | 1781 | 100% |  | 2023-06-30 | 2023-06-30 | 0d | 2023-06-30 | 2023-06-30 |  |  | must start on 2023-06-30 |  | SIT |  | 5.0 | Complete |  | Code Bodies | COMPLETE |  |  |  |  | Andrew Margan | Systems Integration Testing (SIT) |
| 1783 | 1.4.7.3 | **REC CP R0044** |  | 173d | 2022-10-31 A | 2023-06-29 A |  | 100% |  | 2022-10-31 | 2023-06-29 | 173d | 2022-10-31 | 2023-06-29 |  |  |  |  | SIT |  | 5.0 |  |  | N/A |  |  |  | N/A |  | N/A | Systems Integration Testing (SIT) |
| 1784 | 1.4.7.3.1 | Monitor progress to implementation date |  | 173d | 2022-10-31 A | 2023-06-28 A |  | 100% |  | 2022-10-31 | 2023-06-28 | 173d | 2022-10-31 | 2023-06-28 |  |  |  |  | SIT |  | 5.0 | Complete |  | CPT | COMPLETE |  |  | Code Bodies |  | Andrew Margan | Systems Integration Testing (SIT) |
| 1785 | 1.4.7.3.2 | REC CP R0044 Implementation Date | milestone | 0d | 2023-06-29 A | 2023-06-29 A | 1784 | 100% |  | 2023-06-29 | 2023-06-29 | 0d | 2023-06-29 | 2023-06-29 |  |  | must start on 2023-06-29 |  | SIT |  | 5.0 | Complete |  | Code Bodies | COMPLETE |  |  |  |  | Andrew Margan | Systems Integration Testing (SIT) |
| 1786 | 1.5 | **NON SIT LDSO QUALIFICATION** |  | 489d? | 2023-11-07 A | 2025-09-19 |  | 63% | 178.83d? | 2023-11-07 | 2025-08-22 | 343d | 2024-01-29 | 2024-07-05 | 32162d |  |  | -0 | Non-SIT LDSO Qualification |  |  |  | QAG | N/A |  |  |  | N/A |  | N/A | Systems Integration Testing (SIT) |
| 1787 | 1.5.1 | **Approach Planning** |  | 208d | 2023-11-07 A | 2024-08-22 A |  | 100% |  | 2023-11-07 | 2024-08-22 | 208d |  |  |  |  |  | -0 | Non-SIT LDSO Qualification | -386.67 | 5.24 |  |  | N/A |  |  |  | N/A |  | N/A |  |
| 1788 | 1.5.1.1 | Develop Draft Testing Approach & Plan |  | 61d | 2023-11-07 A | 2024-01-30 A |  | 100% |  | 2023-11-07 | 2024-01-30 | 61d |  |  |  |  | start no earlier than 2023-11-07 |  | Non-SIT LDSO Qualification |  | 5.24 | Complete |  | Non-SIT LDSO | COMPLETE |  |  | Non-SIT LDSO |  | Ben Wickins |  |
| 1789 | 1.5.1.2 | Draft Testing Approach & Plan Issued to LDSO for Review |  | 1d | 2024-01-31 A | 2024-01-31 A | 1788 | 100% |  | 2024-01-31 | 2024-01-31 | 1d |  |  |  |  |  |  | Non-SIT LDSO Qualification |  | 5.24 | Complete |  | Non-SIT LDSO | COMPLETE |  |  | Non-SIT LDSO |  | Ben Wickins |  |
| 1790 | 1.5.1.3 | LDSO Review Complete |  | 10d | 2024-02-01 A | 2024-02-14 A | 1789 | 100% |  | 2024-02-01 | 2024-02-14 | 10d |  |  |  |  |  |  | Non-SIT LDSO Qualification |  | 5.24 | Complete |  | LDSOs | COMPLETE |  |  | Non-SIT LDSO |  | Ben Wickins |  |
| 1791 | 1.5.1.4 | Update Following LDSO Review |  | 14d | 2024-02-15 A | 2024-03-05 A | 1790 | 100% |  | 2024-02-15 | 2024-03-05 | 14d |  |  |  |  |  |  | Non-SIT LDSO Qualification |  | 5.24 | Complete |  | Non-SIT LDSO | COMPLETE |  |  | Non-SIT LDSO, Code Bodies |  | Ben Wickins |  |
| 1792 | 1.5.1.5 | QWG Review of Approach & Plan |  | 1d | 2024-03-12 A | 2024-03-12 A | 1791FS+4d | 100% |  | 2024-03-12 | 2024-03-12 | 1d |  |  |  |  |  |  | Non-SIT LDSO Qualification |  | 5.24 | Complete |  | Non-SIT LDSO, PP | COMPLETE |  |  | Non-SIT LDSO, Code Bodies |  | Ben Wickins |  |
| 1793 | 1.5.1.6 | QAG Approval for Approach & Plan | milestone | 0d | 2024-03-21 A | 2024-03-21 A | 1792FS+7d | 100% |  | 2024-03-21 | 2024-03-21 | 0d |  |  |  |  |  |  | Non-SIT LDSO Qualification |  | 5.24 | Complete |  | Code Bodies | COMPLETE |  |  | Non-SIT LDSO,Code Bodies |  | Ben Wickins |  |
| 1794 | 1.5.1.7 | Confirmation of Participants for Non-SIT LDSO Qualification Testing | milestone | 0d | 2024-03-21 A | 2024-03-21 A | 1793 | 100% |  | 2024-03-21 | 2024-03-21 | 0d | 2024-01-29 | 2024-01-29 |  |  |  |  | Non-SIT LDSO Qualification |  | 5.24 | Complete | QAG (Non-SIT LDSO) | Non-SIT LDSO | COMPLETE | T3-QU-0011 | T3 | SI Test, PP, IPA |  | Ben Wickins | Systems Integration Testing (SIT) |
| 1795 | 1.5.1.8 | Update to Annex 1 for internal review (NF, Not Operational) |  | 15d | 2024-03-18 A | 2024-04-05 A | 1074 | 100% |  | 2024-03-18 | 2024-04-05 | 15d |  |  |  |  |  |  | Non-SIT LDSO Qualification |  | 5.24 | Complete |  | Non-SIT LDSO | COMPLETE |  |  | PP, Code Bodies |  | Ben Wickins |  |
| 1796 | 1.5.1.9 | Non-Functional, Operational & Migration Approaches Socialised with Code Bodies & LDSO & Feedback Actioned |  | 86d | 2024-04-08 A | 2024-08-05 A | 1795 | 100% |  | 2024-04-08 | 2024-08-05 | 86d |  |  |  |  |  |  | Non-SIT LDSO Qualification |  | 5.27 | Complete |  | Non-SIT LDSO | COMPLETE |  |  | PP, Code Bodies |  | Ben Wickins |  |
| 1797 | 1.5.1.10 | QWG Review Operational, Non-Functional & Migration Annexes of Approach & Plan |  | 1d | 2024-08-13 A | 2024-08-13 A | 1796FS+5d | 100% |  | 2024-08-13 | 2024-08-13 | 1d |  |  |  |  |  |  | Non-SIT LDSO Qualification |  | 5.27 | Complete |  | Non-SIT LDSO, PP | COMPLETE |  |  | Non-SIT LDSO, PP, Code Bodies |  | Ben Wickins |  |
| 1798 | 1.5.1.11 | Update Following QWG Review |  | 6d | 2024-08-14 A | 2024-08-21 A | 1797 | 100% |  | 2024-08-14 | 2024-08-21 | 6d |  |  |  |  |  |  | Non-SIT LDSO Qualification |  | 5.27 | Complete |  | Non-SIT LDSO, PP | COMPLETE |  |  | Non-SIT LDSO, Code Bodies |  | Ben Wickins |  |
| 1799 | 1.5.1.12 | QAG Approval for Operational, Non-Functional & Migration Annexes of Approach & Plan | milestone | 0d | 2024-08-22 A | 2024-08-22 A | 1798FS+1d, 1794, 1077 | 100% |  | 2024-08-22 | 2024-08-22 | 0d |  |  |  |  |  |  | Non-SIT LDSO Qualification |  | 5.29 | Complete | QAG (Non-SIT LDSO) | Code Bodies | COMPLETE | T3-QU-0110 | T3 | Non-SIT LDSO, Code Bodies |  | Ben Wickins |  |

Notes:
- 1795: Guidance: 26/3: Linked to the development of SIT non functional plan
- 1799: Guidance: 18/7/24: Date change from 18/7/24 to 22/8/24 approved at QAG on 18/7/24

| ID | WBS | Task | Type | Duration | Start | Finish | Predecessors | Complete | Baseline start | Baseline finish | Baseline duration | Baseline 1 start | Baseline 1 finish | Constraint | Baseline cost | Responsible | Involved | Text9 | Task Status | Update Version | MHHS Resource Name | Sched Status | RAG | Milestone ID | Text29 | Tier | MHHS Programme Phase |
| --- | --- | --- | --- | --- | --- | --- | --- | --- | --- | --- | --- | --- | --- | --- | --- | --- | --- | --- | --- | --- | --- | --- | --- | --- | --- | --- | --- |
| 1800 | 1.5.2 | **Functional Test Cases & Scenarios** |  | 58d | 2024-01-30 A | 2024-04-18 A |  | 100% | 2024-01-30 | 2024-04-18 | 58d |  |  |  | -0 | N/A | N/A | Non-SIT LDSO Qualification | -385.67 | 5.24 | N/A |  |  |  |  |  |  |
| 1801 | 1.5.2.1 | **Functional Test Cases & Scenarios Batch 1** |  | 8d | 2024-01-30 A | 2024-02-08 A |  | 100% | 2024-01-30 | 2024-02-08 | 8d |  |  |  | -0 | N/A | N/A | Non-SIT LDSO Qualification |  | 5.24 | N/A |  |  |  |  |  |  |
| 1802 | 1.5.2.1.1 | Walkthrough Test Cases & Scenarios Batch 1 with Code Bodies |  | 1d | 2024-01-30 A | 2024-01-30 A | 1788SS+60d | 100% | 2024-01-30 | 2024-01-30 | 1d |  |  |  |  | Non-SIT LDSO | Non-SIT LDSO, Code Bodies | Non-SIT LDSO Qualification |  | 5.24 | Ben Wickins | Complete | COMPLETE |  |  |  |  |
| 1803 | 1.5.2.1.2 | Walkthrough Test Cases & Scenarios Batch 1 with LDSO |  | 1d | 2024-02-01 A | 2024-02-01 A | 1802 | 100% | 2024-02-01 | 2024-02-01 | 1d |  |  |  |  | LDSO, Non-SIT LDSO | LDSO, Non-SIT LDSO | Non-SIT LDSO Qualification |  | 5.24 | Ben Wickins | Complete | COMPLETE |  |  |  |  |
| 1804 | 1.5.2.1.3 | Action Feedback on Test Cases & Scenarios Batch 1 |  | 5d | 2024-02-02 A | 2024-02-08 A | 1803 | 100% | 2024-02-02 | 2024-02-08 | 5d |  |  |  |  | Non-SIT LDSO | Non-SIT LDSO, LDSO , Code Bodies | Non-SIT LDSO Qualification |  | 5.24 | Ben Wickins | Complete | COMPLETE |  |  |  |  |
| 1805 | 1.5.2.2 | **Functional Test Cases & Scenarios Batch 2** |  | 14d | 2024-02-20 A | 2024-03-08 A |  | 100% | 2024-02-20 | 2024-03-08 | 14d |  |  |  | -0 | N/A | N/A | Non-SIT LDSO Qualification |  | 5.24 | N/A |  |  |  |  |  |  |
| 1806 | 1.5.2.2.1 | Walkthrough Test Cases & Scenarios Batch 2 with Code Bodies |  | 1d | 2024-02-20 A | 2024-02-20 A | 1788SS+75d | 100% | 2024-02-20 | 2024-02-20 | 1d |  |  |  |  | Non-SIT LDSO | Non-SIT LDSO, Code Bodies | Non-SIT LDSO Qualification |  | 5.24 | Ben Wickins | Complete | COMPLETE |  |  |  |  |
| 1807 | 1.5.2.2.2 | Walkthrough Test Cases & Scenarios Batch 2 with LDSO |  | 1d | 2024-03-01 A | 2024-03-01 A | 1806FS+7d | 100% | 2024-03-01 | 2024-03-01 | 1d |  |  |  |  | LDSO, Non-SIT LDSO | LDSO, Non-SIT LDSO | Non-SIT LDSO Qualification |  | 5.24 | Ben Wickins | Complete | COMPLETE |  |  |  |  |
| 1808 | 1.5.2.2.3 | Action Feedback on Test Cases & Scenarios Batch 2 |  | 5d | 2024-03-04 A | 2024-03-08 A | 1807 | 100% | 2024-03-04 | 2024-03-08 | 5d |  |  |  |  | Non-SIT LDSO | Non-SIT LDSO, LDSO , Code Bodies | Non-SIT LDSO Qualification |  | 5.24 | Ben Wickins | Complete | COMPLETE |  |  |  |  |
| 1809 | 1.5.2.3 | **Functional Test Cases & Scenarios Batch 3** |  | 13d | 2024-03-20 A | 2024-04-05 A |  | 100% | 2024-03-20 | 2024-04-05 | 13d |  |  |  | -0 | N/A | N/A | Non-SIT LDSO Qualification |  | 5.24 | N/A |  |  |  |  |  |  |
| 1810 | 1.5.2.3.1 | Walkthrough Test Cases & Scenarios Batch 3 with Code Bodies |  | 1d | 2024-03-20 A | 2024-03-20 A | 1788SS+96d | 100% | 2024-03-20 | 2024-03-20 | 1d |  |  |  |  | Non-SIT LDSO | Non-SIT LDSO, Code Bodies | Non-SIT LDSO Qualification |  | 5.24 | Ben Wickins | Complete | COMPLETE |  |  |  |  |
| 1811 | 1.5.2.3.2 | Walkthrough Test Cases & Scenarios Batch 3 with LDSO |  | 1d | 2024-03-28 A | 2024-03-28 A | 1810FS+5d | 100% | 2024-03-28 | 2024-03-28 | 1d |  |  |  |  | LDSO, Non-SIT LDSO | LDSO, Non-SIT LDSO | Non-SIT LDSO Qualification |  | 5.24 | Ben Wickins | Complete | COMPLETE |  |  |  |  |
| 1812 | 1.5.2.3.3 | Action Feedback on Test Cases & Scenarios Batch 3 |  | 6d | 2024-03-29 A | 2024-04-05 A | 1811 | 100% | 2024-03-29 | 2024-04-05 | 6d |  |  |  |  | Non-SIT LDSO | Non-SIT LDSO, LDSO , Code Bodies | Non-SIT LDSO Qualification |  | 5.24 | Ben Wickins | Complete | COMPLETE |  |  |  |  |
| 1813 | 1.5.2.4 | Test Cases & Scenarios Batch 1-3 Discussion at QWG |  | 1d | 2024-04-09 A | 2024-04-09 A | 1804, 1808, 1812FS+1d | 100% | 2024-04-09 | 2024-04-09 | 1d |  |  |  |  | Non-SIT LDSO, PP | Non-SIT LDSO, Code Bodies | Non-SIT LDSO Qualification |  | 5.24 | Ben Wickins | Complete | COMPLETE |  |  |  |  |
| 1814 | 1.5.2.5 | Action QWG Feedback on Test Cases & Scenarios Batch 1-3 |  | 2d | 2024-04-10 A | 2024-04-11 A | 1813 | 100% | 2024-04-10 | 2024-04-11 | 2d |  |  |  |  | Non-SIT LDSO | Non-SIT LDSO, Code Bodies | Non-SIT LDSO Qualification |  | 5.24 | Ben Wickins | Complete | COMPLETE |  |  |  |  |
| 1815 | 1.5.2.6 | Batch 1-3 Non-SIT LDSO QT Functional Test Scenarios and Test Cases approved | milestone | 0d | 2024-04-18 A | 2024-04-18 A | 1814FS+5d | 100% | 2024-04-18 | 2024-04-18 | 0d |  |  |  |  | Code Bodies | Non-SIT LDSO, Code Bodies | Non-SIT LDSO Qualification |  | 5.24 | Ben Wickins | Complete | COMPLETE | T3-QU-0069 | QAG (Non-SIT LDSO) | T3 |  |
| 1816 | 1.5.3 | **Test Execution Schedule** |  | 161d | 2024-04-19 A | 2024-11-29 A |  | 100% | 2024-04-19 | 2024-11-29 | 90d | 2024-01-29 | 2024-04-26 |  | -0 | N/A | N/A | Non-SIT LDSO Qualification |  | 5.24 | N/A |  |  |  |  |  | Systems Integration Testing (SIT) |
| 1817 | 1.5.3.1 | Draft Test Delivery Schedule for Functional and Operational Testing |  | 20d | 2024-04-19 A | 2024-05-16 A | 1815 | 100% | 2024-04-19 | 2024-05-16 | 20d | 2024-01-29 | 2024-03-22 |  |  | Non-SIT LDSO | SI Test, PP, Non-SIT LDSO | Non-SIT LDSO Qualification |  | 5.24 | Ben Wickins | Complete | COMPLETE |  |  |  | Systems Integration Testing (SIT) |
| 1818 | 1.5.3.2 | Socialise Test Delivery Schedule with Code Bodies & LDSO for Review & Action Feedback |  | 37d | 2024-05-17 A | 2024-07-08 A | 1817 | 100% | 2024-05-17 | 2024-07-08 | 37d |  |  |  |  | Non-SIT LDSO | LDSO, Code Bodies, Non-SIT LDSO | Non-SIT LDSO Qualification |  | 5.24 | Ben Wickins | Complete | COMPLETE |  |  |  |  |
| 1819 | 1.5.3.3 | Agree Test Execution Timetable Format at QWG, Including Anonymisation Requirements |  | 1d | 2024-07-09 A | 2024-07-09 A | 1818 | 100% | 2024-07-09 | 2024-07-09 | 1d | 2024-03-25 | 2024-04-19 |  |  | Non-SIT LDSO, PP | Non-SIT LDSO, Code Bodies | Non-SIT LDSO Qualification |  | 5.24 | Ben Wickins | Complete | COMPLETE |  |  |  | Systems Integration Testing (SIT) |
| 1820 | 1.5.3.4 | Action QWG Feedback |  | 3d | 2024-07-10 A | 2024-07-12 A | 1819 | 100% | 2024-07-10 | 2024-07-12 | 3d |  |  |  |  | Non-SIT LDSO, PP | Non-SIT LDSO, Code Bodies | Non-SIT LDSO Qualification |  | 5.24 | Ben Wickins | Complete | COMPLETE |  |  |  |  |
| 1821 | 1.5.3.5 | Agree Test Execution Timetable Format at QAG, Including Anonymisation Requirements | milestone | 0d | 2024-07-18 A | 2024-07-18 A | 1820FS+4d | 100% | 2024-07-18 | 2024-07-18 | 0d |  |  |  |  | Code Bodies | Non-SIT LDSO, Code Bodies | Non-SIT LDSO Qualification |  | 5.29 | Ben Wickins | Complete | COMPLETE | T3-QU-0111 | QAG (Non-SIT LDSO) | T3 |  |
| 1822 | 1.5.3.6 | Qualification Testing for Non-SIT LDSOs (Functional, Migration, NFT, Operational) Test Execution Schedule Complete | milestone | 0d | 2024-11-29 A | 2024-11-29 A | 1799 | 100% | 2024-11-29 | 2024-11-29 | 0d | 2024-04-26 | 2024-04-26 | finish no earlier than 2024-11-29 |  | Non-SIT LDSO | Non-SIT LDSO, Code Bodies, PP | Non-SIT LDSO Qualification |  | 5.29 | Ben Wickins | Complete | COMPLETE | T3-QU-0008 | QAG (Non-SIT LDSO) | T3 | Systems Integration Testing (SIT) |
| 1823 | 1.5.4 | **Functional, Non-Functional, Operational & Migration Test Scenarios & Cases** |  | 110d | 2024-03-22 A | 2024-08-22 A |  | 100% | 2024-03-22 | 2024-08-22 | 110d |  |  |  | -0 | N/A | N/A | Non-SIT LDSO Qualification |  | 5.24 | N/A |  |  |  |  |  |  |
| 1824 | 1.5.4.1 | Test Scenarios & Cases - Functional - Drafted, Reviewed |  | 14d | 2024-04-01 A | 2024-04-18 A | 1793 | 100% | 2024-04-01 | 2024-04-18 | 14d |  |  |  |  | Non-SIT LDSO | Non-SIT LDSO, LDSO, Code Bodies | Non-SIT LDSO Qualification |  | 5.24 | Ben Wickins | Complete | COMPLETE |  |  |  |  |
| 1825 | 1.5.4.2 | Test Scenarios & Cases- Functional - Approved at QAG | milestone | 0d | 2024-04-18 A | 2024-04-18 A | 1824 | 100% | 2024-04-18 | 2024-04-18 | 0d |  |  |  |  | Non-SIT LDSO | Non-SIT LDSO, LDSO, Code Bodies | Non-SIT LDSO Qualification |  | 5.24 | Ben Wickins | Complete | COMPLETE | T3-QU-0070 | QAG (Non-SIT LDSO) | T3 |  |
| 1826 | 1.5.4.3 | Test Scenarios & Cases - Non-Functional - Drafted, Reviewed |  | 110d | 2024-03-22 A | 2024-08-22 A | 1793, 1094FF | 100% | 2024-03-22 | 2024-08-22 | 110d |  |  |  |  | Non-SIT LDSO | Non-SIT LDSO, LDSO, Code Bodies | Non-SIT LDSO Qualification |  | 5.24 | Ben Wickins | Complete | COMPLETE |  |  |  |  |
| 1827 | 1.5.4.4 | Test Scenarios & Cases - Non-Functional - Approved at QAG | milestone | 0d | 2024-08-22 A | 2024-08-22 A | 1826 | 100% | 2024-08-22 | 2024-08-22 | 0d |  |  |  |  | Non-SIT LDSO | Non-SIT LDSO, LDSO, Code Bodies | Non-SIT LDSO Qualification |  | 5.29 | Ben Wickins | Complete | COMPLETE | T3-QU-0071 | QAG (Non-SIT LDSO) | T3 |  |
| 1828 | 1.5.4.5 | Test Scenarios & Cases - Migration - Drafted, Reviewed |  | 45d | 2024-03-22 A | 2024-05-23 A | 1793 | 100% | 2024-03-22 | 2024-05-23 | 45d |  |  |  |  | Non-SIT LDSO | Non-SIT LDSO, LDSO, Code Bodies | Non-SIT LDSO Qualification |  | 5.24 | Ben Wickins | Complete | COMPLETE |  |  |  |  |
| 1829 | 1.5.4.6 | Test Scenarios & Cases - Migration - Approved at QAG | milestone | 0d | 2024-05-23 A | 2024-05-23 A | 1828 | 100% | 2024-05-23 | 2024-05-23 | 0d |  |  |  |  | Non-SIT LDSO | Non-SIT LDSO, LDSO, Code Bodies | Non-SIT LDSO Qualification |  | 5.24 | Ben Wickins | Complete | COMPLETE | T3-QU-0072 | QAG (Non-SIT LDSO) | T3 |  |
| 1830 | 1.5.4.7 | Test Scenarios & Cases - Operational - Drafted, Reviewed |  | 59d | 2024-06-03 A | 2024-08-22 A | 1793FS+51d | 100% | 2024-06-03 | 2024-08-22 | 59d |  |  |  |  | Non-SIT LDSO | Non-SIT LDSO, LDSO, Code Bodies | Non-SIT LDSO Qualification |  | 5.24 | Ben Wickins | Complete | COMPLETE |  |  |  |  |
| 1831 | 1.5.4.8 | Test Scenarios & Cases - Operational - Approved at QAG | milestone | 0d | 2024-08-22 A | 2024-08-22 A | 1830, 1094FF | 100% | 2024-08-22 | 2024-08-22 | 0d |  |  |  |  | Non-SIT LDSO | Non-SIT LDSO, LDSO, Code Bodies | Non-SIT LDSO Qualification |  | 5.29 | Ben Wickins | Complete | COMPLETE | T3-QU-0073 | QAG (Non-SIT LDSO) | T3 |  |

Notes:
- 1822: 09/12/24 - All 9 LDSOs have now baselined schedules, so this is now complete. / Guidance: 18/7/24: Date change from 15/8/24 to 22/8/24 approved at QAG on 18/7/24
- 1827: Guidance: 18/7/24: Date change from 18/7/24 to 22/8/24 approved at QAG on 18/7/24
- 1831: Guidance: 18/7/24: Date change from 18/7/24 to 22/8/24 approved at QAG on 18/7/24

| ID | WBS | Task | Type | Duration | Start | Finish | Predecessors | Complete | Remaining | Baseline start | Baseline finish | Baseline duration | Total slack | Free slack | Constraint | Deadline | Baseline cost | Responsible | Involved | Text9 | Task Status | Update Version | MHHS Resource Name | Sched Status | RAG | Milestone ID | Text29 | Tier |
| --- | --- | --- | --- | --- | --- | --- | --- | --- | --- | --- | --- | --- | --- | --- | --- | --- | --- | --- | --- | --- | --- | --- | --- | --- | --- | --- | --- | --- |
| 1832 | 1.5.5 | **Test Data** |  | 345d | 2024-01-22 A | 2025-05-16 |  | 65% | 120.02d | 2024-01-22 | 2025-05-16 | 241d | 32252d |  |  |  | -0 | N/A | N/A | Non-SIT LDSO Qualification | -385.67 | 5.24 | N/A |  |  |  |  |  |
| 1833 | 1.5.5.1 | Test Data Plan Drafted & Reviewed |  | 89d | 2024-01-22 A | 2024-05-23 A | 1788 | 100% |  | 2024-01-22 | 2024-05-23 | 89d |  |  |  |  |  | Code Bodies | Non-SIT LDSO, Code Bodies | Non-SIT LDSO Qualification |  | 5.24 | Ben Wickins | Complete | COMPLETE |  |  |  |
| 1834 | 1.5.5.2 | Non-SIT LDSO QT Test Data Plan Approved by QAG | milestone | 0d | 2024-05-23 A | 2024-05-23 A | 1833 | 100% |  | 2024-05-23 | 2024-05-23 | 0d |  |  |  |  |  | Code Bodies | Non-SIT LDSO, Code Bodies | Non-SIT LDSO Qualification |  | 5.24 | Ben Wickins | Complete | COMPLETE | T3-QU-0074 | QAG (Non-SIT LDSO) | T3 |
| 1835 | 1.5.5.3 | Develop Test Data Matrices |  | 10d | 2024-05-24 A | 2024-06-06 A | 1834 | 100% |  | 2024-05-24 | 2024-06-06 | 10d |  |  |  |  |  | Non-SIT LDSO | Non-SIT LDSO | Non-SIT LDSO Qualification |  | 5.24 | Ben Wickins | Complete | COMPLETE |  |  |  |
| 1836 | 1.5.5.4 | Test Data Cut |  | 17d | 2024-05-24 A | 2024-06-17 A | 1834 | 100% |  | 2024-05-24 | 2024-06-17 | 17d |  |  |  |  |  | PP, Non-SIT LDSO | PP, Non-SIT LDSO | Non-SIT LDSO Qualification |  | 5.24 | Ben Wickins | Complete | COMPLETE |  |  |  |
| 1837 | 1.5.5.5 | Test Data Cut Complete | milestone | 0d | 2024-06-17 A | 2024-06-17 A | 1836, 1835 | 100% |  | 2024-06-17 | 2024-06-17 | 0d |  |  |  |  |  | PP, Non-SIT LDSO | PP, Non-SIT LDSO | Non-SIT LDSO Qualification |  | 5.27 | Ben Wickins | Complete | COMPLETE | T3-QU-0112 | QAG (Non-SIT LDSO) | T3 |
| 1838 | 1.5.5.6 | Test Data Reviewed by the Programme |  | 39d | 2024-06-18 A | 2024-08-09 A | 1837 | 100% |  | 2024-06-18 | 2024-08-09 | 39d |  |  |  |  |  | Non-SIT LDSO | PP, Non-SIT LDSO | Non-SIT LDSO Qualification |  | 5.24 | Ben Wickins | Complete | COMPLETE |  |  |  |
| 1839 | 1.5.5.7 | Test Data Loaded |  | 85d | 2024-08-12 A | 2024-12-06 | 1838 | 90% | 8.5d | 2024-08-12 | 2024-12-06 | 17d | 32252d | 0d |  |  |  | Non-SIT LDSO | PP, Non-SIT LDSO | Non-SIT LDSO Qualification |  | 5.24 | Ben Wickins | Green | RED |  |  |  |
| 1840 | 1.5.5.8 | Test Data Signed Off | milestone | 0d | 2024-12-06 | 2024-12-06 | 1839 |  |  | 2024-12-06 | 2024-12-06 | 0d | 32252d | 0d |  |  |  | Non-SIT LDSO | PP, Non-SIT LDSO | Non-SIT LDSO Qualification | -13.29 | 5.25 | Ben Wickins | Green | RED | T3-QU-0113 | QAG (Non-SIT LDSO) | T3 |
| 1841 | 1.5.5.9 | Test Execution Data Support |  | 115d | 2024-12-09 | 2025-05-16 | 1840 |  |  | 2024-12-09 | 2025-05-16 | 79d | 32252d |  |  |  |  | Non-SIT LDSO | Non-SIT LDSO | Non-SIT LDSO Qualification | -10.67 | 5.24 | Ben Wickins | Green | GREEN |  |  |  |
| 1842 | 1.5.6 | **Tooling** |  | 148d | 2024-01-31 A | 2024-08-23 A |  | 100% |  | 2024-01-31 | 2024-08-23 | 148d |  |  |  |  | -0 | N/A | N/A | Non-SIT LDSO Qualification | -385.67 | 5.24 | N/A |  |  |  |  |  |
| 1843 | 1.5.6.1 | Design Approach & Set-Up ADO Tool for Test & Defect Management Tool |  | 53d | 2024-01-31 A | 2024-04-12 A | 1788 | 100% |  | 2024-01-31 | 2024-04-12 | 53d |  |  |  |  |  | Non-SIT LDSO | Non-SIT LDSO, SI Test | Non-SIT LDSO Qualification |  | 5.24 | Ben Wickins | Complete | COMPLETE |  |  |  |
| 1844 | 1.5.6.2 | Develop Training Requirements & Materials Inc. Day in the Life |  | 87d | 2024-04-15 A | 2024-08-13 A | 1843 | 100% |  | 2024-04-15 | 2024-08-13 | 87d |  |  |  |  |  | Non-SIT LDSO | Non-SIT LDSO, SI Test | Non-SIT LDSO Qualification |  | 5.24 | Ben Wickins | Complete | COMPLETE |  |  |  |
| 1845 | 1.5.6.3 | ADO Launch complete |  | 1d | 2024-08-23 A | 2024-08-23 A | 1844, 1825, 1829, 1831 | 100% |  | 2024-08-23 | 2024-08-23 | 1d |  |  |  |  |  | Non-SIT LDSO | Non-SIT LDSO | Non-SIT LDSO Qualification |  | 5.24 | Ben Wickins | Complete | COMPLETE |  |  |  |
| 1846 | 1.5.7 | **Pre-Integration Testing** |  | 258d | 2024-01-31 A | 2025-01-24 |  | 78% | 56.46d | 2024-01-31 | 2024-11-29 | 174d | 32332d |  |  |  | -0 | N/A | N/A | Non-SIT LDSO Qualification | -385.67 | 5.24 | N/A |  |  |  |  |  |
| 1847 | 1.5.7.1 | PIT Guidance & Templates & Approach & Plans Developed |  | 106d | 2024-02-05 A | 2024-07-01 A | 1788FS+3d | 100% |  | 2024-02-05 | 2024-07-01 | 106d |  |  |  |  |  | Non-SIT LDSO | Non-SIT LDSO, LDSO | Non-SIT LDSO Qualification |  | 5.27 | Ben Wickins | Complete | COMPLETE |  |  |  |
| 1848 | 1.5.7.2 | PIT Test Approach & Plan Deadline for Submission for Non-SIT LDSO​ QT | milestone | 0d | 2024-07-01 A | 2024-07-01 A | 1847 | 100% |  | 2024-07-01 | 2024-07-01 | 0d |  |  |  |  |  | Non-SIT LDSO | Non-SIT LDSO, LDSO | Non-SIT LDSO Qualification |  | 5.28 | Ben Wickins | Complete | COMPLETE | T3-QU-0075 | QAG (Non-SIT LDSO) | T3 |
| 1849 | 1.5.7.3 | Develop and agree PIT Test Scenarios |  | 20d | 2024-07-02 A | 2024-07-29 A | 1848 | 100% |  | 2024-07-02 | 2024-07-29 | 31d |  |  |  |  |  | Non-SIT LDSO | Non-SIT LDSO, Code Bodies, LDSO | Non-SIT LDSO Qualification |  | 5.24 | Ben Wickins | Complete | COMPLETE |  |  |  |
| 1850 | 1.5.7.4 | PIT Execution (Functional and Migration) | manual | 45d | 2024-09-30 A | 2024-11-29 | 1849 | 36% | 29d | 2024-09-30 | 2024-11-29 | 45d |  |  | start no earlier than 2024-09-30 |  |  | Non-SIT LDSO | Non-SIT LDSO, LDSO | Non-SIT LDSO Qualification |  | 5.24 | Ben Wickins | Green | RED |  |  |  |
| 1851 | 1.5.7.5 | PIT Execution (Non-Functional and Operational) |  | 90d | 2024-09-23 A | 2025-01-24 | 1849 | 21% | 71d | 2024-09-23 | 2025-01-24 | 0d | 32332d | 0d |  |  |  |  |  | Non-SIT LDSO Qualification |  | 5.24 |  | Green | GREEN |  |  |  |
| 1852 | 1.5.7.6 | Non-SIT LDSO Participants have submitted functional PIT Test Completion Report & evidence for QT Entry​ | milestone | 0d | 2024-11-29 | 2024-11-29 | 1850 |  |  | 2024-11-29 | 2024-11-29 | 0d | 32372d | 15d |  |  |  | Non-SIT LDSO | Non-SIT LDSO, LDSO | Non-SIT LDSO Qualification | -20.29 | 5.24 | Ben Wickins | Green | RED | T3-QU-0076 | QAG (Non-SIT LDSO) | T3 |
| 1853 | 1.5.7.7 | Non-SIT LDSO Participants have submitted non-functional PIT Test Completion Report | milestone | 0d | 2025-01-24 | 2025-01-24 | 1851 |  |  | 2025-01-27 | 2025-01-27 | 0d | 32332d |  |  |  |  |  |  | Non-SIT LDSO Qualification | 35.71 | 5.24 | Ben Wickins | Green | GREEN |  |  |  |
| 1854 | 1.5.7.8 | **Placing Reliance - Code Body & LDSO Functional and Migration** |  | 147d | 2024-01-31 A | 2024-08-22 A |  | 100% |  | 2024-01-31 | 2024-08-22 | 147d |  |  |  |  | -0 | N/A | N/A | Non-SIT LDSO Qualification | -100.67 | 5.24 | N/A |  |  |  |  |  |
| 1855 | 1.5.7.8.1 | Placing Reliance Submitted & Reviewed |  | 21d | 2024-01-31 A | 2024-02-28 A | 1788 | 100% |  | 2024-01-31 | 2024-02-28 | 21d |  |  |  | 2024-01-05 |  | LDSO, Non-SIT LDSO | LDSO, Non-SIT LDSO | Non-SIT LDSO Qualification |  | 5.24 | Ben Wickins | Complete | COMPLETE |  |  |  |
| 1856 | 1.5.7.8.2 | Define & Agree QT Testing for Each LDSO |  | 22d | 2024-02-29 A | 2024-03-29 A | 1855 | 100% |  | 2024-02-29 | 2024-03-29 | 22d |  |  |  |  |  | Non-SIT LDSO | LDSO, Non-SIT LDSO | Non-SIT LDSO Qualification |  | 5.24 | Ben Wickins | Complete | COMPLETE |  |  |  |
| 1857 | 1.5.7.8.3 | Develop Test Scope & Reliance Submissions |  | 20d | 2024-04-01 A | 2024-04-26 A | 1856 | 100% |  | 2024-04-01 | 2024-04-26 | 20d |  |  |  |  |  | Non-SIT LDSO | LDSO, Non-SIT LDSO, Code Bodies | Non-SIT LDSO Qualification |  | 5.24 | Ben Wickins | Complete | COMPLETE |  |  |  |
| 1858 | 1.5.7.8.4 | Review and Consultation |  | 84d | 2024-04-29 A | 2024-08-22 A | 1857, 1799FF | 100% |  | 2024-04-29 | 2024-08-22 | 84d |  |  |  |  |  | Non-SIT LDSO | LDSO, Non-SIT LDSO | Non-SIT LDSO Qualification |  | 5.27 | Ben Wickins | Complete | COMPLETE |  |  |  |

Notes:
- 1839: 03/12/24 - Data load is continuing in support of test readiness assessments but additional support has been required by some LDSOs to load some data elements. LDSOs are clear that approved data is a condition of test readiness approval.
- 1840: 03/12/24 - This activity will be signed off by Nic Farely, after assurance is given by Paul Morgan that the test data recieve meets our requirements. Data load is continuing in support of test readiness assessments but additional support has been required by some LDSOs to load some data elements. 6/9 LDSOs have test data signed off, the other 3 have outstanding actions before they can be complete but this is expected to be before the Testing Window start.
- 1850: 09/12/24 - At least one participant has not completed PIT Execution, hence why this is Red. This is not expected to delay testing start.
- 1851: 21/10/24 - Proposed to add this as a new activity, to go to QAG for approval.
- 1852: 09/12/24 - At least one participant has not completed PIT Execution, hence why this is Red. This is not expected to delay testing start.
- 1853: 21/10/24 - Proposed to add this as a new activity, to go to QAG for approval.

| ID | WBS | Task | Type | Duration | Start | Finish | Predecessors | Complete | Remaining | Baseline start | Baseline finish | Baseline duration | Baseline 1 start | Baseline 1 finish | Total slack | Free slack | Constraint | Deadline | Baseline cost | Responsible | Involved | Text9 | Task Status | Update Version | MHHS Resource Name | Sched Status | RAG | Milestone ID | Text29 | Tier | MHHS Programme Phase | Action |
| --- | --- | --- | --- | --- | --- | --- | --- | --- | --- | --- | --- | --- | --- | --- | --- | --- | --- | --- | --- | --- | --- | --- | --- | --- | --- | --- | --- | --- | --- | --- | --- | --- |
| 1859 | 1.5.7.9 | **Placing Reliance - Code Body & LDSO Non Functional and Operational** |  | 49d | 2024-06-17 A | 2024-08-22 A |  | 100% |  | 2024-06-17 | 2024-08-22 | 49d |  |  |  |  |  |  | -0 | N/A | N/A | Non-SIT LDSO Qualification | -100.67 | 5.25 | N/A |  |  |  |  |  |  |  |
| 1860 | 1.5.7.9.1 | Placing Reliance Submitted & Reviewed |  | 32d | 2024-06-17 A | 2024-07-30 A | 1797FF-10d | 100% |  | 2024-06-17 | 2024-07-30 | 32d |  |  |  |  |  |  |  | LDSO, Non-SIT LDSO | LDSO, Non-SIT LDSO | Non-SIT LDSO Qualification |  | 5.27 | Ben Wickins | Complete | COMPLETE |  |  |  |  |  |
| 1861 | 1.5.7.9.2 | Review and Consultation |  | 17d | 2024-07-31 A | 2024-08-22 A | 1860 | 100% |  | 2024-07-31 | 2024-08-22 | 17d |  |  |  |  |  |  |  | Non-SIT LDSO | LDSO, Non-SIT LDSO | Non-SIT LDSO Qualification |  | 5.27 | Ben Wickins | Complete | COMPLETE |  |  |  |  |  |
| 1862 | 1.5.7.9.3 | PP Test Scope Presented at QAG | milestone | 0d | 2024-08-22 A | 2024-08-22 A | 1861, 1858 | 100% |  | 2024-08-22 | 2024-08-22 | 0d |  |  |  |  |  |  |  | Non-SIT LDSO | LDSO, Non-SIT LDSO | Non-SIT LDSO Qualification |  | 5.29 | Ben Wickins | Complete | COMPLETE | T3-QU-0077 | QAG (Non-SIT LDSO) | T3 |  |  |
| 1863 | 1.5.8 | **LDSO Test Readiness Reporting** |  | 71d | 2024-04-19 A | 2024-07-26 A |  | 100% |  | 2024-04-19 | 2024-07-26 | 118d |  |  |  |  |  |  | -0 | N/A | N/A | Non-SIT LDSO Qualification |  | 5.24 | N/A |  |  |  |  |  |  |  |
| 1864 | 1.5.8.1 | Interim Test Readiness Report & Plan Developed & Reviewed |  | 71d | 2024-04-19 A | 2024-07-26 A | 1815 | 100% |  | 2024-04-19 | 2024-07-26 | 71d |  |  |  |  |  |  |  | Non-SIT LDSO, LDSO | Non-SIT LDSO, LDSO | Non-SIT LDSO Qualification |  | 5.24 | Ben Wickins | Complete | COMPLETE |  |  |  |  |  |
| 1865 | 1.5.8.2 | Test Plan Submission to MHHS Programme For Review | milestone | 0d | 2024-07-26 A | 2024-07-26 A | 1864 | 100% |  | 2024-07-26 | 2024-07-26 | 0d |  |  |  |  |  |  |  | LDSO | Non-SIT LDSO, LDSO | Non-SIT LDSO Qualification |  | 5.30 | Ben Wickins | Complete | COMPLETE | T3-QU-0114 | QAG (Non-SIT LDSO) | T3 |  |  |
| 1866 | 1.5.9 | **Test Environment** |  | 163d | 2024-04-17 A | 2024-11-29 A |  | 100% |  | 2024-04-17 | 2024-11-29 | 111d | 2024-01-29 | 2024-07-05 |  |  |  |  | -0 | N/A | N/A | Non-SIT LDSO Qualification |  | 5.24 | N/A |  |  |  |  |  | Systems Integration Testing (SIT) |  |
| 1867 | 1.5.9.1 | Define Test Harness Requirements and Sign-Off with SRO |  | 13d | 2024-04-17 A | 2024-05-03 A | 522 | 100% |  | 2024-04-17 | 2024-05-03 | 13d |  |  |  |  |  |  |  | Non-SIT LDSO | Non-SIT LDSO,SRO,Sims and Ems | Non-SIT LDSO Qualification |  | 5.24 | Ben Wickins | Complete | COMPLETE |  |  |  |  |  |
| 1868 | 1.5.9.2 | Central System (DIP Env & Helix Test Harness) Test Environment DBT |  | 163d | 2024-04-17 A | 2024-11-29 A | 522 | 100% |  | 2024-04-17 | 2024-11-29 | 92d |  |  |  |  | finish no earlier than 2024-11-29 |  |  | LDSO | Non SIT-LDSO, LDSO | Non-SIT LDSO Qualification |  | 5.24 | Ben Wickins | Complete | COMPLETE |  |  |  |  |  |
| 1869 | 1.5.9.3 | Coordinate LDSO Environment Preparation |  | 101d | 2024-07-12 A | 2024-11-29 A | 1868FF | 100% |  | 2024-07-12 | 2024-11-29 | 30d |  |  |  |  |  |  |  | Non-SIT LDSO | Non-SIT LDSO | Non-SIT LDSO Qualification |  | 5.24 | Ben Wickins | Complete | COMPLETE |  |  |  |  |  |
| 1870 | 1.5.9.4 | DIP available for Onboarding |  | 1d | 2024-08-01 A | 2024-08-01 A |  | 100% |  | 2024-08-01 | 2024-08-01 | 1d |  |  |  |  | start no earlier than 2024-08-01 |  |  | Test Env | Test Env, Non-SIT LDSO | Non-SIT LDSO Qualification |  | 5.24 | Ben Wickins | Complete | COMPLETE |  |  |  |  | 11/3: Ask Simon B for the link |
| 1871 | 1.5.9.5 | Qualification Testing for Non-SIT LDSOs Participants' environments) Ready to start DIP onboarding (incl. certificates and security compliance) | milestone | 0d | 2024-08-05 A | 2024-08-05 A | 1870FS+2d | 100% |  | 2024-08-05 | 2024-08-05 | 0d | 2024-04-26 | 2024-04-26 |  |  |  |  |  | Non-SIT LDSO | Code Bodies, PP, IPA | Non-SIT LDSO Qualification |  | 5.30 | Ben Wickins | Complete | COMPLETE | T3-QU-0009 | QAG (Non-SIT LDSO) | T3 | Systems Integration Testing (SIT) |  |
| 1872 | 1.5.9.6 | LDSO Test Environments Connection Confirmed to UIT Environment | milestone | 0d | 2024-11-29 A | 2024-11-29 A | 1871FS+32d, 1869 | 100% |  | 2024-11-29 | 2024-11-29 | 0d |  |  |  |  |  |  |  | Non-SIT LDSO | Code Bodies, PP, IPA | Non-SIT LDSO Qualification |  | 5.24 | Ben Wickins | Complete | COMPLETE | T3-QU-0078 | QAG (Non-SIT LDSO) | T3 |  |  |
| 1873 | 1.5.10 | **Test Readiness** |  | 124d | 2024-07-02 A | 2024-12-20 |  | 90% | 11.85d | 2024-07-02 | 2024-12-20 | 76d |  |  | 32357d |  |  |  | -0 | N/A | N/A | Non-SIT LDSO Qualification |  | 5.24 | N/A |  |  |  |  |  |  |  |
| 1874 | 1.5.10.1 | Preparation for Interim Test Readiness Report |  | 19d | 2024-07-02 A | 2024-07-26 A | 1848 | 100% |  | 2024-07-02 | 2024-07-26 | 30d |  |  |  |  |  |  |  | LDSO | LDSO, Non-SIT LDSO | Non-SIT LDSO Qualification |  | 5.24 | Ben Wickins | Complete | COMPLETE |  |  |  |  |  |
| 1875 | 1.5.10.2 | Interim Test Readiness Report Submission to MHHS Programme for Review | milestone | 0d | 2024-07-26 A | 2024-07-26 A | 1874 | 100% |  | 2024-07-26 | 2024-07-26 | 0d |  |  |  |  |  |  |  | LDSO | Non-SIT LDSO, LDSO | Non-SIT LDSO Qualification |  | 5.25 | Ben Wickins | Complete | COMPLETE | T3-QU-0116 | QAG (Non-SIT LDSO) | T3 |  |  |
| 1876 | 1.5.10.3 | LDSO Update Readiness Report & Final Assurance by Programme |  | 99d | 2024-07-29 A | 2024-12-12 | 1875 | 95% | 4.95d | 2024-07-29 | 2024-12-12 | 25d |  |  | 7d | 0d |  |  |  | Non-SIT LDSO, LDSO | Non-SIT LDSO, LDSO | Non-SIT LDSO Qualification |  | 5.24 | Ben Wickins | Green | GREEN |  |  |  |  |  |
| 1877 | 1.5.10.4 | Final Test Readiness Report Submitted to MHHS Programme |  | 1d | 2024-12-13 | 2024-12-13 | 1876 |  |  | 2024-12-13 | 2024-12-13 | 1d |  |  | 32357d | 0d |  |  |  | LDSO | Non-SIT LDSO, Code Bodies | Non-SIT LDSO Qualification | -6.67 | 5.24 | Ben Wickins | Green | GREEN |  |  |  |  |  |
| 1878 | 1.5.10.5 | Final Programme Assurance of LDSO Test Readiness |  | 6d | 2024-12-13 | 2024-12-20 | 1876 |  |  | 2024-12-13 | 2024-12-20 | 21d |  |  | 7d | 0d |  |  |  | Non-SIT LDSO | Non-SIT LDSO, LDSO | Non-SIT LDSO Qualification | -6.67 | 5.24 | Ben Wickins | Green | GREEN |  |  |  |  |  |
| 1879 | 1.5.10.6 | Qualification Testing for Non-SIT LDSOs (Functional, Migration, NFT, Operational) Programme Test Readiness confirmed | milestone | 0d | 2024-12-20 | 2024-12-20 | 1877FS+5d, 1852, 1825, 1827, 1829, 1867 |  |  | 2024-12-20 | 2024-12-20 | 0d | 2024-07-05 | 2024-07-05 | 32357d |  |  |  |  | Non-SIT LDSO | SI Test, PP, Non-SIT LDSO | Non-SIT LDSO Qualification | 0.71 | 5.24 | Ben Wickins | Green | RED | T3-QU-0007 | QAG (Non-SIT LDSO) | T3 | Systems Integration Testing (SIT) |  |
| 1880 | 1.5.10.7 | Qualification Testing for Non-SIT LDSOs (Functional, Migration, NFT, Operational) Test Readiness Confirmed (Final Test Readiness Review for LDSO) | milestone | 0d | 2024-12-20 | 2024-12-20 | 1876, 1878 |  |  | 2024-12-20 | 2024-12-20 | 0d | 2024-07-05 | 2024-07-05 | 7d | 0d |  |  |  | LDSO | SI Test, PP, LDSO | Non-SIT LDSO Qualification | 0.71 | 5.24 | Ben Wickins | Green | RED | T2-QU-0550 | QAG (Non-SIT LDSO) | T2 | Systems Integration Testing (SIT) |  |
| 1881 | 1.5.11 | **Test Window** |  | 165d? | 2025-01-06 | 2025-08-22 |  |  |  | 2025-01-06 | 2025-05-16 | 59d |  |  | 7d |  |  |  | -0 | N/A | N/A | Non-SIT LDSO Qualification | -527.67 | 6.0 | N/A |  |  |  | QAG (Non-SIT LDSO) |  |  |  |
| 1882 | 1.5.11.1 | **All Non-SIT LDSOs Qualification Testing** |  | 94d | 2025-01-06 | 2025-05-16 | 1880, 1872 |  |  | 2025-01-06 | 2025-05-16 | 59d |  |  | 1d |  |  |  |  | LDSO | Non-SIT LDSO,Code Bodies, LDSO | Non-SIT LDSO Qualification | 118.33 | 6.0 | Ben Wickins |  |  |  | QAG (Non-SIT LDSO) |  |  |  |
| 1883 | 1.5.11.1.1 | Non-SIT LDSO QT Test Execution Starts | milestone | 0d | 2025-01-06 | 2025-01-06 | 1880FS+11d |  |  | 2025-01-06 | 2025-01-06 | 0d |  |  | 7d | 0d | start no earlier than 2024-11-01 |  |  | Non-SIT LDSO | Non-SIT LDSO, LDSO, Code Bodies | Non-SIT LDSO Qualification | 17.71 | 6.0 | Ben Wickins | Green | GREEN | T3-QU-0115 | QAG (Non-SIT LDSO) | T3 |  |  |
| 1884 | 1.5.11.1.2 | LDSO Alpha |  | 86d | 2025-01-06 | 2025-05-05 | 1883FS-1d |  |  | 2025-01-06 | 2025-05-05 |  |  |  | 9d | 8d |  |  |  | LDSO |  | Non-SIT LDSO Qualification | 17.33 | 6.15 | Ben Wickins | Green | GREEN |  | QAG (Non-SIT LDSO) |  |  |  |
| 1885 | 1.5.11.1.3 | LDSO Bravo |  | 59d | 2025-01-06 | 2025-03-27 | 1883FS-1d |  |  | 2025-01-06 | 2025-03-27 |  |  |  | 36d | 35d |  |  |  | LDSO |  | Non-SIT LDSO Qualification | 17.33 | 6.15 | Ben Wickins | Green | GREEN |  | QAG (Non-SIT LDSO) |  |  |  |
| 1886 | 1.5.11.1.4 | LDSO Charlie |  | 88d | 2025-01-06 | 2025-05-07 | 1883FS-1d |  |  | 2025-01-06 | 2025-05-07 |  |  |  | 7d | 6d |  |  |  | LDSO |  | Non-SIT LDSO Qualification | 17.33 | 6.15 | Ben Wickins | Green | GREEN |  | QAG (Non-SIT LDSO) |  |  |  |
| 1887 | 1.5.11.1.5 | LDSO Delta |  | 83d | 2025-01-06 | 2025-04-30 | 1883FS-1d |  |  | 2025-01-06 | 2025-04-30 |  |  |  | 12d | 11d |  |  |  | LDSO |  | Non-SIT LDSO Qualification | 17.33 | 6.15 | Ben Wickins | Green | GREEN |  | QAG (Non-SIT LDSO) |  |  |  |
| 1888 | 1.5.11.1.6 | LDSO Echo |  | 69d | 2025-01-06 | 2025-04-10 | 1883FS-1d |  |  | 2025-01-06 | 2025-04-10 |  |  |  | 26d | 25d |  |  |  | LDSO |  | Non-SIT LDSO Qualification | 17.33 | 6.15 | Ben Wickins | Green | GREEN |  | QAG (Non-SIT LDSO) |  |  |  |
| 1889 | 1.5.11.1.7 | LDSO Foxtrot |  | 44d | 2025-01-20 | 2025-03-20 | 1883FS+9d |  |  | 2025-01-20 | 2025-03-20 |  |  |  | 41d | 40d |  |  |  | LDSO |  | Non-SIT LDSO Qualification | 31.33 | 6.15 | Ben Wickins | Green | GREEN |  | QAG (Non-SIT LDSO) |  |  |  |
| 1890 | 1.5.11.1.8 | LDSO Golf |  | 66d | 2025-01-06 | 2025-04-07 | 1883FS-1d |  |  | 2025-01-06 | 2025-04-07 |  |  |  | 29d | 28d |  |  |  | LDSO |  | Non-SIT LDSO Qualification | 17.33 | 6.15 | Ben Wickins | Green | GREEN |  | QAG (Non-SIT LDSO) |  |  |  |
| 1891 | 1.5.11.1.9 | LDSO Hotel |  | 45d | 2025-01-06 | 2025-03-07 | 1883FS-1d |  |  | 2025-01-06 | 2025-03-07 |  |  |  | 50d | 49d |  |  |  | LDSO |  | Non-SIT LDSO Qualification | 17.33 | 6.15 | Ben Wickins | Green | GREEN |  | QAG (Non-SIT LDSO) |  |  |  |
| 1892 | 1.5.11.1.10 | LDSO India |  | 86d | 2025-01-06 | 2025-05-05 | 1883FS-1d |  |  | 2025-01-06 | 2025-05-05 |  |  |  | 9d | 8d |  |  |  | LDSO |  | Non-SIT LDSO Qualification | 17.33 | 6.15 | Ben Wickins | Green | GREEN |  | QAG (Non-SIT LDSO) |  |  |  |
| 1893 | 1.5.11.1.11 | Qualification Testing for Non-SIT LDSOs (Functional, Migration, NFT, Operational) 1 End | milestone | 0d | 2025-05-16 | 2025-05-16 | 1884, 1885, 1886, 1887, 1888, 1889, 1890, 1891, 1892 |  |  | 2025-05-16 | 2025-05-16 | 0d |  |  | 1d | 0d | start no earlier than 2025-05-16 | 2025-05-16 |  | LDSO |  | Non-SIT LDSO Qualification | 147.33 | 6.0 | Ben Wickins | Green | GREEN | T3-QU-0010 | QAG (Non-SIT LDSO) | T3 |  |  |
| 1894 | 1.5.11.2 | Potential for non-SIT LDSO QT Regression for Qualification |  | 70d? | 2025-05-19 | 2025-08-22 | 1893FS+1d |  |  | 2025-05-19 | 2025-08-22 | 0d |  |  | 32182d |  |  |  |  | Non-SIT LDSO |  | Non-SIT LDSO Qualification | 150.33 | 6.12 | Ben Wickins | Green | GREEN |  | QAG (Non-SIT LDSO) |  |  |  |

Notes:
- 1862: Guidance: 18/7/24: Date change from 18/7/24 to 22/8/24 approved at QAG on 18/7/24
- 1879: 18/12/24 - Milestone RAG'd red because a predecssor activity (T3-QU-0076) is delayed because at least one participant is being delayed, but the factors behind this are internal to them, so not affecting all PPs.
- 1880: 18/12/24 - Milestone RAG'd red because a predecssor activity (T3-QU-0076) is delayed because at least one participant is being delayed, but the factors behind this are internal to them, so not affecting all PPs.
- 1883: 19/12/24 - QAG approved that the QT Test Execution can start on 06/01/25, hence status for this has been set to green, this is despite T3-QU-0007 and T2-QU-0550 RAG'ing red.
- 1884: 19/12/24 - QAG approved the inclusion of restructuring the Test Execution window, plan updated to reflect this.
- 1885: 19/12/24 - QAG approved the inclusion of restructuring the Test Execution window, plan updated to reflect this.
- 1886: 19/12/24 - QAG approved the inclusion of restructuring the Test Execution window, plan updated to reflect this.
- 1887: 19/12/24 - QAG approved the inclusion of restructuring the Test Execution window, plan updated to reflect this.
- 1888: 19/12/24 - QAG approved the inclusion of restructuring the Test Execution window, plan updated to reflect this.
- 1889: 19/12/24 - QAG approved the inclusion of restructuring the Test Execution window, plan updated to reflect this.
- 1890: 19/12/24 - QAG approved the inclusion of restructuring the Test Execution window, plan updated to reflect this.
- 1891: 19/12/24 - QAG approved the inclusion of restructuring the Test Execution window, plan updated to reflect this.
- 1892: 19/12/24 - QAG approved the inclusion of restructuring the Test Execution window, plan updated to reflect this.
- 1894: 11/11/24 - New activity added for potential non-SIT LDSO QT Regression for Qualification. Programme to confirm scope and duration. This is because only two participants will miss the submission deadline due to internal issues to them.

| ID | WBS | Task | Type | Duration | Start | Finish | Predecessors | Complete | Remaining | Baseline start | Baseline finish | Baseline duration | Baseline 1 start | Baseline 1 finish | Total slack | Free slack | Constraint | Baseline cost | Responsible | Involved | Text9 | Update Version | MHHS Resource Name | Text29 | Task Status | Sched Status | RAG | Milestone ID | Tier | MHHS Programme Phase |
| --- | --- | --- | --- | --- | --- | --- | --- | --- | --- | --- | --- | --- | --- | --- | --- | --- | --- | --- | --- | --- | --- | --- | --- | --- | --- | --- | --- | --- | --- | --- |
| 1895 | 1.5.12 | **Test Result Assurance** |  | 29d | 2025-04-21 | 2025-05-29 |  |  |  | 2025-04-21 | 2025-05-29 | 60d |  |  | 31622d |  |  | -0 | N/A | N/A | Non-SIT LDSO Qualification | 6.0 | N/A | QAG (Non-SIT LDSO) |  |  |  |  |  |  |
| 1896 | 1.5.12.1 | LDSOs Develop & Submit Test Report (QT Test Completion Report) |  | 19d | 2025-04-21 | 2025-05-16 | 1893FF |  |  | 2025-04-21 | 2025-05-16 | 19d |  |  | 31622d | 0d |  |  | LDSO | Non-SIT LDSO, LDSO | Non-SIT LDSO Qualification | 6.0 | Ben Wickins | QAG (Non-SIT LDSO) | 122.33 | Green | GREEN |  |  |  |
| 1897 | 1.5.12.2 | Test Reports Reviewed By MHHS & Code Bodies & Finalised |  | 10d | 2025-05-16 | 2025-05-29 | 1896 |  |  | 2025-05-16 | 2025-05-29 | 16d |  |  | 32223d | 0d |  |  | Non-SIT LDSO | Non-SIT LDSO, Code Bodies | Non-SIT LDSO Qualification | 6.0 | Ben Wickins | QAG (Non-SIT LDSO) | 147.33 | Green | GREEN |  |  |  |
| 1898 | 1.5.12.3 | Non-SIT LDSOs submission deadline for their QT Test Completion Report to MHHS Programme | milestone | 0d | 2025-05-29 | 2025-05-29 | 1897, 1882 |  |  | 2025-05-29 | 2025-05-29 | 0d |  |  | 32223d | 61d |  |  | Non-SIT LDSO | Non-SIT LDSO | Non-SIT LDSO Qualification | 6.0 | Ben Wickins | QAG (Non-SIT LDSO) | 160.71 | Green | GREEN | T3-QU-0079 | T3 |  |
| 1899 | 1.5.13 | **Non-SIT LDSO Qualification Closure** |  | 20d | 2025-08-25 | 2025-09-19 |  |  |  | 2025-05-30 | 2025-08-22 | 49d |  |  | 32162d |  |  | -0 | N/A | N/A | Non-SIT LDSO Qualification | 6.0 | N/A | QAG (Non-SIT LDSO) |  |  |  |  |  |  |
| 1900 | 1.5.13.1 | Non-SIT LDSO Qualification Learned Captured |  | 15d | 2025-08-25 | 2025-09-12 | 1898, 1991 |  |  | 2025-05-30 | 2025-06-19 | 15d |  |  | 32162d | 0d |  |  | Non-SIT LDSO | Non-SIT LDSO | Non-SIT LDSO Qualification | 6.0 | Ben Wickins | QAG (Non-SIT LDSO) | 248.33 | Red | RED |  |  |  |
| 1901 | 1.5.13.2 | Non-SIT LDSO Qualification Closure Down |  | 5d | 2025-09-15 | 2025-09-19 | 1900 |  |  | 2025-06-20 | 2025-06-26 | 5d |  |  | 32162d |  |  |  | Non-SIT LDSO | Non-SIT LDSO | Non-SIT LDSO Qualification | 6.0 | Ben Wickins | QAG (Non-SIT LDSO) | 269.33 | Red | RED |  |  |  |
| 1902 | 1.6 | **S & A QUALIFICATION** |  | 843d? | 2023-11-07 A | 2027-01-28 |  | 51% | 410.42d? | 2023-11-07 | 2027-01-28 | 603d | 2024-01-29 | 2024-07-05 | 31808d |  |  | -0 | N/A | N/A | S&A Qualification |  | N/A |  | -461.67 |  |  |  |  | Systems Integration Testing (SIT) |
| 1903 | 1.6.1 | **MHHS Qualification - Qualification Deliverables** |  | 463d | 2023-11-07 A | 2025-08-14 |  | 94% | 28.71d | 2023-11-07 | 2025-08-14 | 349d |  |  | 32178d |  |  | -0 | N/A | N/A | S&A Qualification | 5.24 | N/A |  | -131.67 |  |  |  |  |  |
| 1904 | 1.6.1.1 | **BSC & REC Assessment Criteria** |  | 463d | 2023-11-07 A | 2025-08-14 A |  | 100% |  | 2023-11-07 | 2025-08-14 | 212d |  |  |  |  |  | -0 | N/A | N/A | S&A Qualification | 5.24 | N/A |  | -131.67 |  |  |  |  |  |
| 1905 | 1.6.1.1.1 | Draft BSC Assessment Criteria (Functional) |  | 21d | 2023-11-07 A | 2023-12-05 A |  | 100% |  | 2023-11-07 | 2023-12-05 | 21d |  |  |  |  | finish no earlier than 2023-12-05 |  | Code Bodies | Code Bodies | S&A Qualification | 5.24 | Laura Kennedy |  |  | Complete | COMPLETE |  |  |  |
| 1906 | 1.6.1.1.2 | BSC PAB Review |  | 1d | 2023-12-14 A | 2023-12-14 A |  | 100% |  | 2023-12-14 | 2023-12-14 | 1d |  |  |  |  | start no earlier than 2023-12-14 |  | Code Bodies | Code Bodies | S&A Qualification | 5.24 | Laura Kennedy |  |  | Complete | COMPLETE |  |  |  |
| 1907 | 1.6.1.1.3 | Update BSC Assessment Criteria (Functional, Non-Functional, Migration) |  | 30d | 2024-02-07 A | 2024-03-19 A |  | 100% |  | 2024-02-07 | 2024-03-19 | 30d |  |  |  |  | finish no earlier than 2024-03-19 |  | Code Bodies | Code Bodies | S&A Qualification | 5.24 | Laura Kennedy |  |  | Complete | COMPLETE |  |  |  |
| 1908 | 1.6.1.1.4 | REC & BSC PAB Approval |  | 3d | 2024-03-26 A | 2024-03-28 A |  | 100% |  | 2024-03-26 | 2024-03-28 | 3d |  |  |  |  | start no earlier than 2024-03-28 |  | Code Bodies | Code Bodies | S&A Qualification | 5.24 | Laura Kennedy |  |  | Complete | COMPLETE |  |  |  |
| 1909 | 1.6.1.1.5 | Update BSC Assessment Criteria (Functional, Non-Functional, Migration, Operational) |  | 20d | 2024-07-24 A | 2024-08-20 A |  | 100% |  | 2024-07-24 | 2024-08-20 | 20d |  |  |  |  |  |  | Code Bodies | Code Bodies | S&A Qualification | 5.24 | Laura Kennedy |  |  | Complete | COMPLETE |  |  |  |
| 1910 | 1.6.1.1.6 | Assessment Criteria (Functional, Non-Functional, Migration, Operational) Approved by REC PAB and BSC PAB |  | 250d | 2024-08-29 A | 2025-08-14 A | 1909FS+7d | 100% |  | 2024-08-29 | 2025-08-14 | 0d |  |  |  |  | start no earlier than 2023-09-15 |  | Code Bodies | Code Bodies | S&A Qualification | 5.25 | Laura Kennedy | QAG |  | Complete | COMPLETE | T3-QU-0080 | T3 |  |
| 1911 | 1.6.1.2 | **Qualification Approach and Plan** |  | 194d | 2023-12-04 A | 2024-08-29 A |  | 100% |  | 2023-12-04 | 2024-08-29 | 194d |  |  |  |  |  | -0 | N/A | N/A | S&A Qualification | 5.24 | N/A |  | -131.67 |  |  |  |  |  |
| 1912 | 1.6.1.2.1 | **Qualification Approach and Plan v2** |  | 84d | 2023-12-04 A | 2024-03-28 A |  | 100% |  | 2023-12-04 | 2024-03-28 | 84d |  |  |  |  |  | -0 | N/A | N/A | S&A Qualification | 5.24 | N/A |  | -131.67 |  |  |  |  |  |
| 1913 | 1.6.1.2.1.1 | Draft Qualification Approach and Plan v2 |  | 30d | 2023-12-04 A | 2024-01-12 A |  | 100% |  | 2023-12-04 | 2024-01-12 | 30d |  |  |  |  | finish no earlier than 2024-01-12 |  | Code Bodies | Code Bodies | S&A Qualification | 5.24 | Laura Kennedy |  |  | Complete | COMPLETE |  |  |  |
| 1914 | 1.6.1.2.1.2 | Internal Review (Code Bodies and MHHSP) for Qualification Approach and Plan V2 |  | 10d | 2024-01-15 A | 2024-01-26 A | 1913 | 100% |  | 2024-01-15 | 2024-01-26 | 10d |  |  |  |  | finish no earlier than 2024-01-26 |  | Code Bodies, SI Team, SRO | Code Bodies, SI Team, SRO | S&A Qualification | 5.24 | Laura Kennedy |  |  | Complete | COMPLETE |  |  |  |
| 1915 | 1.6.1.2.1.3 | Industry consultation for Qualification Approach and Plan v2 |  | 11d | 2024-01-31 A | 2024-02-14 A | 1914 | 100% |  | 2024-01-31 | 2024-02-14 | 11d |  |  |  |  | start no earlier than 2024-01-31 |  | Participants | Participants | S&A Qualification | 5.24 | Laura Kennedy |  |  | Complete | COMPLETE |  |  |  |
| 1916 | 1.6.1.2.1.4 | Update Qualification Approach and Plan v2 post industry consultation |  | 10d | 2024-02-15 A | 2024-02-28 A | 1915 | 100% |  | 2024-02-15 | 2024-02-28 | 10d |  |  |  |  |  |  | Code Bodies | Code Bodies | S&A Qualification | 5.24 | Laura Kennedy |  |  | Complete | COMPLETE |  |  |  |
| 1917 | 1.6.1.2.1.5 | QWG Endorsement of Qualification Approach and Plan v2 |  | 1d | 2024-03-12 A | 2024-03-12 A |  | 100% |  | 2024-03-12 | 2024-03-12 | 1d |  |  |  |  | start no earlier than 2024-03-12 |  | Code Bodies | Code Bodies | S&A Qualification | 5.24 | Laura Kennedy |  |  | Complete | COMPLETE |  |  |  |
| 1918 | 1.6.1.2.1.6 | QAG Approval of Qualification Approach and Plan v2 |  | 1d | 2024-03-21 A | 2024-03-21 A |  | 100% |  | 2024-03-21 | 2024-03-21 | 1d |  |  |  |  | start no earlier than 2024-03-21 |  | Code Bodies | Code Bodies | S&A Qualification | 5.24 | Laura Kennedy |  |  | Complete | COMPLETE |  |  |  |
| 1919 | 1.6.1.2.1.7 | BSC and REC PAB Approval of Qualification Approach and Plan v2 |  | 3d | 2024-03-26 A | 2024-03-28 A |  | 100% |  | 2024-03-26 | 2024-03-28 | 3d |  |  |  |  | finish no earlier than 2024-03-28 |  | Code Bodies | Code Bodies | S&A Qualification | 5.24 | Laura Kennedy |  |  | Complete | COMPLETE |  |  |  |
| 1920 | 1.6.1.2.1.8 | Functional Testing elements of Qualification Approach & Plan v2 approvement by REC PAB and BSC PAB | milestone | 0d | 2024-03-28 A | 2024-03-28 A | 1919 | 100% |  | 2024-03-28 | 2024-03-28 | 0d |  |  |  |  |  |  | Code Bodies | Code Bodies | S&A Qualification | 5.24 | Laura Kennedy | QAG |  | Complete | COMPLETE | T3-QU-0063 | T3 |  |
| 1921 | 1.6.1.2.1.9 | Migration Testing elements of Qualification Approach & Plan v2 appoved by REC PAB and BSC PAB | milestone | 0d | 2024-03-28 A | 2024-03-28 A | 1919 | 100% |  | 2024-03-28 | 2024-03-28 | 0d |  |  |  |  |  |  | Code Bodies | Code Bodies | S&A Qualification | 5.24 | Laura Kennedy | QAG |  | Complete | COMPLETE | T3-QU-0064 | T3 |  |

| ID | WBS | Task | Type | Duration | Start | Finish | Predecessors | Complete | Remaining | Baseline start | Baseline finish | Baseline duration | Total slack | Constraint | Baseline cost | Responsible | Involved | Text9 | Task Status | Update Version | MHHS Resource Name | Sched Status | RAG | Milestone ID | Text29 | Tier |
| --- | --- | --- | --- | --- | --- | --- | --- | --- | --- | --- | --- | --- | --- | --- | --- | --- | --- | --- | --- | --- | --- | --- | --- | --- | --- | --- |
| 1922 | 1.6.1.2.2 | **Qualification Approach and Plan v3** |  | 84d | 2024-05-06 A | 2024-08-29 A |  | 100% |  | 2024-05-06 | 2024-08-29 | 84d |  |  | -0 | N/A | N/A | S&A Qualification | -133.67 | 5.24 | N/A |  |  |  |  |  |
| 1923 | 1.6.1.2.2.1 | Draft Qualification Approach and Plan v3 |  | 35d | 2024-05-06 A | 2024-06-21 A | 1077 | 100% |  | 2024-05-06 | 2024-06-21 | 35d |  | finish no earlier than 2024-05-17 |  | Code Bodies | Code Bodies | S&A Qualification |  | 5.27 | Laura Kennedy | Complete | COMPLETE |  |  |  |
| 1924 | 1.6.1.2.2.2 | Internal Review (Code Bodies and MHHSP) of Qualification Approach and Plan v3 |  | 10d | 2024-06-24 A | 2024-07-05 A | 1923 | 100% |  | 2024-06-24 | 2024-07-05 | 10d |  |  |  | Code Bodies, SI Team, SRO | Code Bodies, SI Team, SRO | S&A Qualification |  | 5.27 | Laura Kennedy | Complete | COMPLETE |  |  |  |
| 1925 | 1.6.1.2.2.3 | Industry consultation for Qualification Approach and Plan v3 |  | 10d | 2024-07-08 A | 2024-07-19 A | 1924 | 100% |  | 2024-07-08 | 2024-07-19 | 10d |  |  |  | Participants | Participants | S&A Qualification |  | 5.27 | Laura Kennedy | Complete | COMPLETE |  |  |  |
| 1926 | 1.6.1.2.2.4 | Update Qualification Approach and Plan v3 Post-Consultation |  | 10d | 2024-07-22 A | 2024-08-02 A | 1925 | 100% |  | 2024-07-22 | 2024-08-02 | 10d |  |  |  | Code Bodies | Code Bodies | S&A Qualification |  | 5.27 | Laura Kennedy | Complete | COMPLETE |  |  |  |
| 1927 | 1.6.1.2.2.5 | QWG Endorsement of Qualification Approach and Plan v3 |  | 1d | 2024-08-13 A | 2024-08-13 A | 1926FS+6d | 100% |  | 2024-08-13 | 2024-08-13 | 1d |  |  |  | Code Bodies | Code Bodies | S&A Qualification |  | 5.27 | Laura Kennedy | Complete | COMPLETE |  |  |  |
| 1928 | 1.6.1.2.2.6 | QAG Approval of Qualification Approach and Plan v3 | milestone | 0d | 2024-08-22 A | 2024-08-22 A | 1927FS+7d | 100% |  | 2024-08-22 | 2024-08-22 | 0d |  |  |  | Code Bodies | Code Bodies | S&A Qualification |  | 5.27 | Laura Kennedy | Complete | COMPLETE | T3-QU-0081 | QAG |  |
| 1929 | 1.6.1.2.2.7 | BSC and REC PAB Approval of Qualification Approach and Plan v3 |  | 3d | 2024-08-27 A | 2024-08-29 A | 1928FS+2d | 100% |  | 2024-08-27 | 2024-08-29 | 3d |  |  |  | Code Bodies | Code Bodies | S&A Qualification |  | 5.27 | Laura Kennedy | Complete | COMPLETE |  |  |  |
| 1930 | 1.6.1.2.2.8 | Non-Functional Testing elements of Qualification Approach and Plan v3 approved by REC PAB and BSC PAB | milestone | 0d | 2024-08-29 A | 2024-08-29 A | 1929 | 100% |  | 2024-08-29 | 2024-08-29 | 0d |  |  |  | Code Bodies | Code Bodies | S&A Qualification |  | 5.27 | Laura Kennedy | Complete | COMPLETE | T3-QU-0065 | QAG | T3 |
| 1931 | 1.6.1.3 | **Qualification Assessment Document** |  | 346d | 2023-12-22 A | 2025-04-18 |  | 85% | 52.89d | 2023-12-22 | 2025-03-07 | 316d | 32262d |  | -0 | N/A | N/A | S&A Qualification | -131.67 | 5.24 | N/A |  |  |  |  |  |
| 1932 | 1.6.1.3.1 | **Qualification Assessment Document v1** |  | 70d | 2023-12-22 A | 2024-03-28 A |  | 100% |  | 2023-12-22 | 2024-03-28 | 70d |  |  | -0 | N/A | N/A | S&A Qualification | -131.67 | 5.24 | N/A |  |  |  |  |  |
| 1933 | 1.6.1.3.1.1 | Draft Qualification Assessment Document v1 |  | 30d | 2023-12-22 A | 2024-02-01 A |  | 100% |  | 2023-12-22 | 2024-02-01 | 30d |  | finish no earlier than 2024-02-01 |  | Code Bodies | Code Bodies | S&A Qualification |  | 5.24 | Laura Kennedy | Complete | COMPLETE |  |  |  |
| 1934 | 1.6.1.3.1.2 | Internal Review (Code Bodies and MHHSP) of Qualification Assessment Document v1 |  | 10d | 2024-02-01 A | 2024-02-14 A |  | 100% |  | 2024-02-01 | 2024-02-14 | 10d |  | finish no earlier than 2024-02-14 |  | Code Bodies, SI Team, SRO | Code Bodies, SI Team, SRO | S&A Qualification |  | 5.24 | Laura Kennedy | Complete | COMPLETE |  |  |  |
| 1935 | 1.6.1.3.1.3 | Industry consultation for Qualification Assessment Document v1 |  | 11d | 2024-02-16 A | 2024-03-01 A |  | 100% |  | 2024-02-16 | 2024-03-01 | 11d |  | start no earlier than 2024-02-16 |  | Participants | Participants | S&A Qualification |  | 5.24 | Laura Kennedy | Complete | COMPLETE |  |  |  |
| 1936 | 1.6.1.3.1.4 | Update Post-Consultation for Qualification Assessment Document v1 |  | 10d | 2024-03-04 A | 2024-03-15 A | 1935 | 100% |  | 2024-03-04 | 2024-03-15 | 10d |  |  |  | Code Bodies | Code Bodies | S&A Qualification |  | 5.24 | Laura Kennedy | Complete | COMPLETE |  |  |  |
| 1937 | 1.6.1.3.1.5 | BSC and REC PAB Approval of Qualification Assessment Document v1 |  | 3d | 2024-03-26 A | 2024-03-28 A |  | 100% |  | 2024-03-26 | 2024-03-28 | 3d |  | start no earlier than 2024-03-26 |  | Code Bodies | Code Bodies | S&A Qualification |  | 5.24 | Laura Kennedy | Complete | COMPLETE |  |  |  |
| 1938 | 1.6.1.3.1.6 | Qualification Assessment Document v1 approved by REC PAB and BSC PAB | milestone | 0d | 2024-03-28 A | 2024-03-28 A | 1937 | 100% |  | 2024-03-28 | 2024-03-28 | 0d |  |  |  | Code Bodies | Code Bodies | S&A Qualification |  | 5.24 | Laura Kennedy | Complete | COMPLETE | T3-QU-0066 | QAG | T3 |
| 1939 | 1.6.1.3.2 | **Qualification Assessment Document v3** |  | 110d | 2024-03-29 A | 2024-08-29 A |  | 100% |  | 2024-03-29 | 2024-08-29 | 110d |  |  | -0 | N/A | N/A | S&A Qualification | -131.67 | 5.24 | N/A |  |  |  |  |  |
| 1940 | 1.6.1.3.2.1 | Draft Qualification Assessment Document V1.1 |  | 26d | 2024-03-29 A | 2024-05-03 A | 1938 | 100% |  | 2024-03-29 | 2024-05-03 | 26d |  |  |  |  |  | S&A Qualification |  | 5.24 | Laura Kennedy | Complete | COMPLETE |  |  |  |
| 1941 | 1.6.1.3.2.2 | Industry Consultation for Qualification Assessment Document V1.1 |  | 12d | 2024-05-06 A | 2024-05-21 A | 1940 | 100% |  | 2024-05-06 | 2024-05-21 | 12d |  |  |  |  |  | S&A Qualification |  | 5.24 | Laura Kennedy | Complete | COMPLETE |  |  |  |
| 1942 | 1.6.1.3.2.3 | Draft Qualification Assessment Document v3 |  | 6d | 2024-06-14 A | 2024-06-21 A | 1210, 1941 | 100% |  | 2024-06-14 | 2024-06-21 | 6d |  |  |  | Code Bodies | Code Bodies | S&A Qualification |  | 5.24 | Laura Kennedy | Complete | COMPLETE |  |  |  |
| 1943 | 1.6.1.3.2.4 | Internal Review (Code Bodies and MHHSP) of Qualification Assessment Document v3 |  | 10d | 2024-06-24 A | 2024-07-05 A | 1942 | 100% |  | 2024-06-24 | 2024-07-05 | 10d |  |  |  | Code Bodies, SI Team, SRO | Code Bodies, SI Team, SRO | S&A Qualification |  | 5.24 | Laura Kennedy | Complete | COMPLETE |  |  |  |
| 1944 | 1.6.1.3.2.5 | Industry consultation for Qualification Assessment Document v3 |  | 10d | 2024-07-08 A | 2024-07-19 A | 1943 | 100% |  | 2024-07-08 | 2024-07-19 | 10d |  |  |  | Participants | Participants | S&A Qualification |  | 5.24 | Laura Kennedy | Complete | COMPLETE |  |  |  |
| 1945 | 1.6.1.3.2.6 | Update Post-Consultation for Qualification Assessment Document v3 |  | 10d | 2024-07-22 A | 2024-08-02 A | 1944 | 100% |  | 2024-07-22 | 2024-08-02 | 10d |  |  |  | Code Bodies | Code Bodies | S&A Qualification |  | 5.24 | Laura Kennedy | Complete | COMPLETE |  |  |  |
| 1946 | 1.6.1.3.2.7 | QWG Endorsement of Qualification Assessment Document v3 |  | 1d | 2024-08-13 A | 2024-08-13 A | 1945FS+6d | 100% |  | 2024-08-13 | 2024-08-13 | 1d |  |  |  | Code Bodies | Code Bodies | S&A Qualification |  | 5.24 | Laura Kennedy | Complete | COMPLETE |  |  |  |
| 1947 | 1.6.1.3.2.8 | QAG Endorsement of Qualification Assessment Document v3 |  | 1d | 2024-08-22 A | 2024-08-22 A | 1946FS+6d | 100% |  | 2024-08-22 | 2024-08-22 | 1d |  |  |  | Code Bodies | Code Bodies | S&A Qualification |  | 5.25 | Laura Kennedy | Complete | COMPLETE | T3-QU-0083 | QAG | T3 |
| 1948 | 1.6.1.3.2.9 | BSC and REC PAB Approval of Qualification Assessment Document v3 |  | 3d | 2024-08-27 A | 2024-08-29 A | 1947FS+2d | 100% |  | 2024-08-27 | 2024-08-29 | 3d |  |  |  | Code Bodies | Code Bodies | S&A Qualification |  | 5.24 | Laura Kennedy | Complete | COMPLETE |  |  |  |
| 1949 | 1.6.1.3.2.10 | Qualification Assessment Document v3 approved by REC PAB and BSC PAB | milestone | 0d | 2024-08-29 A | 2024-08-29 A | 1948 | 100% |  | 2024-08-29 | 2024-08-29 | 0d |  |  |  | Code Bodies | Code Bodies | S&A Qualification |  | 5.24 | Laura Kennedy | Complete | COMPLETE | T3-QU-0067 | QAG | T3 |

| ID | WBS | Task | Type | Duration | Start | Finish | Predecessors | Complete | Remaining | Baseline start | Baseline finish | Baseline duration | Baseline 1 start | Baseline 1 finish | Total slack | Free slack | Constraint | Baseline cost | Responsible | Involved | Text9 | Task Status | Update Version | MHHS Resource Name | Sched Status | RAG | Milestone ID | Text29 | Tier | MHHS Programme Phase |
| --- | --- | --- | --- | --- | --- | --- | --- | --- | --- | --- | --- | --- | --- | --- | --- | --- | --- | --- | --- | --- | --- | --- | --- | --- | --- | --- | --- | --- | --- | --- |
| 1950 | 1.6.1.3.3 | **Qualification Assessment Document Portal** |  | 315d | 2024-02-05 A | 2025-04-18 |  | 72% | 88.42d | 2024-02-05 | 2025-03-07 | 285d |  |  | 32262d |  |  | -0 | N/A | N/A | S&A Qualification | -131.67 | 5.24 | N/A |  |  |  |  |  |  |
| 1951 | 1.6.1.3.3.1 | Design Completion |  | 30d | 2024-02-05 A | 2024-03-15 A |  | 100% |  | 2024-02-05 | 2024-03-15 | 30d |  |  |  |  | finish no earlier than 2024-03-15 |  | QAD Portal Dev Team | QAD Portal Dev Team | S&A Qualification |  | 5.24 | Laura Kennedy | Complete | COMPLETE |  |  |  |  |
| 1952 | 1.6.1.3.3.2 | Qualification Assessment Document Portal Build |  | 30d | 2024-03-18 A | 2024-04-26 A | 1951 | 100% |  | 2024-03-18 | 2024-04-26 | 30d |  |  |  |  |  |  | QAD Portal Dev Team | QAD Portal Dev Team | S&A Qualification |  | 5.24 | Laura Kennedy | Complete | COMPLETE |  |  |  |  |
| 1953 | 1.6.1.3.3.3 | Qualification Assessment Document Internal Testing |  | 20d | 2024-04-29 A | 2024-05-24 A | 1952 | 100% |  | 2024-04-29 | 2024-05-24 | 20d |  |  |  |  |  |  | QAD Portal Dev Team. Code Bodies | QAD Portal Dev Team. Code Bodies | S&A Qualification |  | 5.24 | Laura Kennedy | Complete | COMPLETE |  |  |  |  |
| 1954 | 1.6.1.3.3.4 | Qualification Assessment Document Portal Training and Onboarding Material Creation |  | 20d | 2024-05-27 A | 2024-06-21 A | 1953 | 100% |  | 2024-05-27 | 2024-06-21 | 20d |  |  |  |  |  |  | QAD Portal Dev Team | QAD Portal Dev Team | S&A Qualification |  | 5.24 | Laura Kennedy | Complete | COMPLETE |  |  |  |  |
| 1955 | 1.6.1.3.3.5 | Qualification Assessment Document Portal Webinar (Date TBC) |  | 1d | 2024-06-18 A | 2024-06-18 A |  | 100% |  | 2024-06-18 | 2024-06-18 | 1d |  |  |  |  | start no earlier than 2024-06-18 |  | QAD Portal Dev Team | QAD Portal Dev Team | S&A Qualification |  | 5.24 | Laura Kennedy | Complete | COMPLETE |  |  |  |  |
| 1956 | 1.6.1.3.3.6 | SIT Participant QAD Application Creation in Portal |  | 10d | 2024-12-09 A | 2024-12-20 | 1954FS+120d | 60% | 4d | 2024-12-09 | 2024-12-20 | 10d |  |  | 32347d | 0d |  |  | Code Bodies | Code Bodies | S&A Qualification |  | 5.24 | Laura Kennedy | Green | GREEN |  |  |  |  |
| 1957 | 1.6.1.3.3.7 | Non-SIT LDSO Participant QAD Application Creation in Portal |  | 10d | 2024-12-09 A | 2024-12-20 | 1954FS+120d | 60% | 4d | 2024-12-09 | 2024-12-20 | 10d |  |  | 32346d | 0d |  |  | Code Bodies | Code Bodies | S&A Qualification |  | 5.24 | Laura Kennedy | Green | GREEN |  |  |  |  |
| 1958 | 1.6.1.3.3.8 | QT Wave 1 Participant QAD Application Creation in Portal |  | 10d | 2025-04-07 | 2025-04-18 | 1954FS+205d |  |  | 2025-04-07 | 2025-04-18 | 10d |  |  | 31579d | 0d |  |  | Code Bodies | Code Bodies | S&A Qualification | 108.33 | 6.1 | Laura Kennedy | Green | GREEN |  |  |  |  |
| 1959 | 1.6.1.3.3.9 | QT Wave 2 Participant QAD Application Creation in Portal |  | 10d | 2024-10-28 | 2024-11-08 | 1954FS+90d |  |  | 2024-10-28 | 2024-11-08 | 10d |  |  | 31578d | 0d |  |  | Code Bodies | Code Bodies | S&A Qualification | -52.67 | 6.1 | Laura Kennedy | Green | GREEN |  |  |  |  |
| 1960 | 1.6.1.3.3.10 | QT Wave 3 Participant QAD Application Creation in Portal |  | 10d | 2024-12-30 | 2025-01-10 | 1954FS+135d |  |  | 2024-12-30 | 2025-01-10 | 10d |  |  | 31582d | 0d |  |  | Code Bodies | Code Bodies | S&A Qualification | 10.33 | 6.1 | Laura Kennedy | Green | GREEN |  |  |  |  |
| 1961 | 1.6.1.3.3.11 | QT Wave 4 Participant QAD Application Creation in Portal |  | 10d | 2025-02-24 | 2025-03-07 | 1954FS+175d |  |  | 2025-02-24 | 2025-03-07 | 10d |  |  | 31573d | 0d |  |  | Code Bodies | Code Bodies | S&A Qualification | 66.33 | 6.1 | Laura Kennedy | Green | GREEN |  |  |  |  |
| 1962 | 1.6.1.3.3.12 | Update to Qualification Assessment Document Portal post QAD V3 |  | 10d | 2024-08-30 A | 2024-09-12 A | 1949 | 100% |  | 2024-08-30 | 2024-09-12 | 10d |  |  |  |  |  |  | QAD Portal Dev Team | QAD Portal Dev Team | S&A Qualification |  | 6.1 | Laura Kennedy | Complete | COMPLETE |  |  |  |  |
| 1963 | 1.6.1.3.3.13 | Update to Qualification Assessment Document Portal post QAD V3 Complete | milestone | 0d | 2024-09-12 A | 2024-09-12 A | 1962 | 100% |  | 2024-09-12 | 2024-09-12 | 0d |  |  |  |  |  |  | QAD Portal Dev Team | QAD Portal Dev Team | S&A Qualification |  | 6.1 | Laura Kennedy | Complete | COMPLETE | T3-QU-0084 | QAG | T3 |  |
| 1964 | 1.6.2 | **MHHS Qualification - SIT Participants** |  | 249d | 2025-01-06 | 2025-12-18 |  |  |  | 2025-01-06 | 2025-12-22 | 194d | 2024-01-29 | 2024-07-05 | 31633d |  |  | -0 | N/A | N/A | S&A Qualification | -133.67 | 6.11 | N/A |  |  |  |  |  | Systems Integration Testing (SIT) |
| 1965 | 1.6.2.1 | Initial QAD Submission Window opens | milestone | 0d | 2025-01-06 | 2025-01-06 | 1956FS+10d |  |  | 2025-01-06 | 2025-01-06 | 0d |  |  | 32347d |  | start no earlier than 2025-01-06 |  | Participants | Participants | S&A Qualification | 17.33 | 6.11 | Laura Kennedy | Green | GREEN |  |  |  |  |
| 1966 | 1.6.2.2 | SIT Participants submit Initial QAD |  | 30d | 2025-01-06 | 2025-02-14 |  |  |  | 2025-01-06 | 2025-02-14 | 29d |  |  | 31633d | 0d | start no earlier than 2025-01-06 |  | Participants | Participants | S&A Qualification | 17.33 | 6.11 | Laura Kennedy | Green | GREEN |  |  |  |  |
| 1967 | 1.6.2.3 | Code Bodies review Initial QAD |  | 36d | 2025-02-14 | 2025-04-04 | 1966FS-1d |  |  | 2025-02-14 | 2025-04-04 | 36d |  |  | 31633d | 0d |  |  | Code Bodies | Code Bodies | S&A Qualification | 56.33 | 6.11 | Laura Kennedy | Green | GREEN |  |  |  |  |
| 1968 | 1.6.2.4 | Completion of Code Bodies review of Initial QAD | milestone | 0d | 2025-04-04 | 2025-04-04 | 1967 |  |  | 2025-04-04 | 2025-04-04 | 0d |  |  | 31633d | 0d |  |  | Code Bodies | Code Bodies | S&A Qualification | 105.71 | 6.11 | Laura Kennedy | Green | GREEN |  |  |  |  |
| 1969 | 1.6.2.5 | **MHHS Qualification - SIT MVC Participants** |  | 114d | 2025-04-07 | 2025-09-11 |  |  |  | 2025-04-07 | 2025-09-11 | 64d |  |  | 31578d |  |  |  | N/A | N/A | S&A Qualification | -154.67 | 6.11 | N/A |  |  |  |  |  |  |
| 1970 | 1.6.2.5.1 | Final QAD Submission Window (MVC) opens | milestone | 0d | 2025-04-07 | 2025-04-07 | 1967, 1963, 1968FS+1d |  |  | 2025-04-07 | 2025-04-07 | 0d |  |  | 31633d | 0d |  |  | Participants | Participants | S&A Qualification | 108.71 | 6.11 | Laura Kennedy | Green | GREEN |  |  |  |  |
| 1971 | 1.6.2.5.2 | SIT MVC Participants submit Final QAD (exc Test Reports) |  | 25d | 2025-04-07 | 2025-05-09 | 1970FS-1d |  |  | 2025-04-07 | 2025-05-09 | 26d |  |  | 31633d | 0d |  |  | Participants | Participants | S&A Qualification | 108.33 | 6.11 | Laura Kennedy | Green | GREEN |  |  |  |  |
| 1972 | 1.6.2.5.3 | Completion of Code Bodies review of Final QAD (MVC) |  | 20d | 2025-05-12 | 2025-06-06 | 1971 |  |  | 2025-05-12 | 2025-06-06 | 19d |  |  | 31633d | 55d |  |  | Code Bodies | Code Bodies | S&A Qualification | 143.33 | 6.11 | Laura Kennedy | Green | GREEN |  |  |  |  |
| 1973 | 1.6.2.5.4 | QAD Sign Off Deadline (MVC) + Test Reports | milestone | 0d | 2025-08-22 | 2025-08-22 | 1633, 1972, 1624 |  |  | 2025-08-22 | 2025-08-22 | 1d |  |  | 31578d | 0d | start no earlier than 2025-07-11 |  | Participants | Participants | S&A Qualification | 245.71 | 6.11 | Laura Kennedy | Green | GREEN |  |  |  |  |
| 1974 | 1.6.2.5.5 | REC Code Manager / BSC PAB Approval of Qualification (MVC) | milestone | 0d | 2025-09-11 | 2025-09-11 | 1973FS+14d |  |  | 2025-09-11 | 2025-09-11 | 0d |  |  | 31578d | 0d |  |  | Code Bodies | Code Bodies | S&A Qualification | 265.71 | 6.11 | Laura Kennedy | Green | GREEN | T3-QU-0085 | QAG | T3 |  |

| ID | WBS | Task | Type | Duration | Start | Finish | Predecessors | Complete | Remaining | Baseline start | Baseline finish | Baseline duration | Total slack | Free slack | Constraint | Baseline cost | Responsible | Involved | Text9 | Task Status | Update Version | MHHS Resource Name | Sched Status | RAG | Milestone ID | Text29 | Tier |
| --- | --- | --- | --- | --- | --- | --- | --- | --- | --- | --- | --- | --- | --- | --- | --- | --- | --- | --- | --- | --- | --- | --- | --- | --- | --- | --- | --- |
| 1975 | 1.6.2.6 | **MHHS Qualification - SIT Non-MVC Participants** |  | 154d | 2025-05-19 | 2025-12-18 |  |  |  | 2025-05-19 | 2025-12-22 | 129d | 31602d |  |  |  | N/A | N/A | S&A Qualification | -154.67 | 6.11 | N/A |  |  |  |  |  |
| 1976 | 1.6.2.6.1 | Final QAD Submission Window (Non-MVC) opens | milestone | 0d | 2025-05-19 | 2025-05-19 | 1968FS+31d |  |  | 2025-05-19 | 2025-05-19 | 0d | 31711d | 0d |  |  | Participants | Participants | S&A Qualification | 150.71 | 6.11 | Laura Kennedy | Green | GREEN |  |  |  |
| 1977 | 1.6.2.6.2 | SIT Non-MVC Participants submit Final QAD |  | 90d | 2025-05-19 | 2025-09-19 | 1976SS-1d |  |  | 2025-05-19 | 2025-09-19 | 86d | 31622d | 0d |  |  | Participants | Participants | S&A Qualification | 150.33 | 6.11 | Laura Kennedy | Green | GREEN |  |  |  |
| 1978 | 1.6.2.6.3 | Completion of Code Bodies review of Final QAD (Non-MVC) |  | 25d | 2025-09-22 | 2025-10-24 | 1977 |  |  | 2025-09-22 | 2025-10-24 | 19d | 31622d | 20d |  |  | Code Bodies | Code Bodies | S&A Qualification | 276.33 | 6.11 | Laura Kennedy | Green | GREEN |  |  |  |
| 1979 | 1.6.2.6.4 | QAD Sign Off Deadline (Non-MVC) |  | 1d | 2025-11-28 | 2025-11-28 | 1978FS+4d, 1655 |  |  | 2025-11-28 | 2025-11-28 | 1d | 31602d | 0d |  |  | Participants | Participants | S&A Qualification | 343.33 | 6.11 | Laura Kennedy | Green | GREEN |  |  |  |
| 1980 | 1.6.2.6.5 | REC Code Manager / BSC PAB Approval of Qualification (Non-MVC) | milestone | 0d | 2025-12-18 | 2025-12-18 | 1979FS+14d |  |  | 2025-12-22 | 2025-12-22 | 0d | 31602d | 0d |  |  | Code Bodies | Code Bodies | S&A Qualification | 363.71 | 6.11 | Laura Kennedy | Green | GREEN | T3-QU-0086 | QAG | T3 |
| 1981 | 1.6.3 | **MHHS Qualification - Non-SIT LDSO** |  | 178d | 2025-01-06 | 2025-09-10 |  |  |  | 2025-01-06 | 2025-09-11 | 115d | 31631d |  |  | -0 | N/A | N/A | S&A Qualification | -133.67 | 6.11 | N/A |  |  |  |  |  |
| 1982 | 1.6.3.1 | Initial QAD Submission window opens | milestone | 0d | 2025-01-06 | 2025-01-06 | 1957FS+11d |  |  | 2025-01-06 | 2025-01-06 | 0d | 32346d |  |  |  | Participants | Participants | S&A Qualification | 17.71 | 6.11 | Laura Kennedy | Green | GREEN |  |  |  |
| 1983 | 1.6.3.2 | Non-SIT LDSO Participants submit initial QAD |  | 30d | 2025-01-06 | 2025-02-14 |  |  |  | 2025-01-06 | 2025-02-14 | 29d | 31631d | 0d | start no earlier than 2025-01-06 |  | Participants | Participants | S&A Qualification | 17.33 | 6.11 | Laura Kennedy | Green | GREEN |  |  |  |
| 1984 | 1.6.3.3 | Non-SIT LDSO QT Participants have submitted their initial QAD | milestone | 0d | 2025-02-14 | 2025-02-14 | 1983 |  |  | 2025-02-14 | 2025-02-14 | 0d | 31631d | 0d |  |  | Participants | Participants | S&A Qualification | 56.71 | 6.11 | Laura Kennedy | Green | GREEN | T3-QU-0087 | QAG | T3 |
| 1985 | 1.6.3.4 | Code Bodies review of Non-SIT LDSO participants Initial QAD |  | 35d | 2025-02-17 | 2025-04-04 | 1984 |  |  | 2025-02-17 | 2025-04-04 | 36d | 31631d | 0d |  |  | Code Bodies | Code Bodies | S&A Qualification | 59.33 | 6.11 | Laura Kennedy | Green | GREEN |  |  |  |
| 1986 | 1.6.3.5 | Completion of Code Bodies review of Initial QAD | milestone | 0d | 2025-04-04 | 2025-04-04 | 1985 |  |  | 2025-04-04 | 2025-04-04 | 0d | 31631d | 0d |  |  | Code Bodies | Code Bodies | S&A Qualification | 105.71 | 6.11 | Laura Kennedy | Green | GREEN |  |  |  |
| 1987 | 1.6.3.6 | Final QAD Submission window opens | milestone | 0d | 2025-04-07 | 2025-04-07 | 1986FS+1d |  |  | 2025-04-07 | 2025-04-07 | 0d | 31631d | 9d |  |  | Participants | Participants | S&A Qualification | 108.71 | 6.11 | Laura Kennedy | Green | GREEN |  |  |  |
| 1988 | 1.6.3.7 | Non-SIT LDSO Participants submit Final QAD |  | 25d | 2025-04-21 | 2025-05-23 | 1896SS, 1987SS |  |  | 2025-04-21 | 2025-05-23 | 26d | 31622d | 0d |  |  | Participants | Participants | S&A Qualification | 122.33 | 6.11 | Laura Kennedy | Green | GREEN |  |  |  |
| 1989 | 1.6.3.8 | Non-SIT LDSO QT Participants have submitted their final QAD | milestone | 0d | 2025-05-23 | 2025-05-23 | 1988 |  |  | 2025-05-23 | 2025-05-23 | 0d | 31622d | 0d |  |  | Participants | Participants | S&A Qualification | 154.71 | 6.11 | Laura Kennedy | Green | GREEN | T3-QU-0088 | QAG | T3 |
| 1990 | 1.6.3.9 | Completion of Code Bodies review of the Final QAD |  | 20d | 2025-05-26 | 2025-06-20 | 1989 |  |  | 2025-05-26 | 2025-06-20 | 19d | 31622d | 40d |  |  | Code Bodies | Code Bodies | S&A Qualification | 157.33 | 6.11 | Laura Kennedy | Green | GREEN |  |  |  |
| 1991 | 1.6.3.10 | QAD Sign Off Deadline (Non-SIT LDSOs) | milestone | 0d | 2025-08-22 | 2025-08-22 | 1990FS+5d, 1633, 1893 |  |  | 2025-08-22 | 2025-08-22 | 1d | 31582d | 0d |  |  | Participants | Participants | S&A Qualification | 245.71 | 6.11 | Laura Kennedy | Green | GREEN |  |  |  |
| 1992 | 1.6.3.11 | BSC PAB & REC Manager approval of Qualification for Non-SIT LDSOs | milestone | 0d | 2025-09-10 | 2025-09-10 | 1991FS+13d |  |  | 2025-09-11 | 2025-09-11 | 0d | 31582d | 0d |  |  | Non-SIT LDSO | Non-SIT LDSO | S&A Qualification | 264.71 | 6.12 | Ben Wickins | Green | GREEN | T2-QU-0500 | QAG (Non-SIT LDSO) | T2 |
| 1993 | 1.6.4 | **MHHS Qualification - Qualification Waves** |  | 814d? | 2023-12-18 A | 2027-01-28 |  | 48% | 424.57d? | 2023-12-18 | 2027-01-28 | 574d | 31808d |  |  | -0 | N/A | N/A | S&A Qualification | -131.67 | 5.24 | N/A |  |  |  |  |  |
| 1994 | 1.6.4.1 | **Qualification Wave Prep** |  | 539d? | 2023-12-18 A | 2026-01-08 |  | 76% | 126.95d? | 2023-12-18 | 2025-12-26 | 424d | 32083d |  |  | -0 | N/A | N/A | S&A Qualification | -131.67 | 5.24 | N/A |  |  |  |  |  |
| 1995 | 1.6.4.1.1 | **Non-SIT Supplier and Agent Test Approach and Plan** |  | 119d | 2023-12-18 A | 2024-05-30 A |  | 100% |  | 2023-12-18 | 2024-05-30 | 118d |  |  |  | -0 | N/A | N/A | S&A Qualification | -133.67 | 5.24 | N/A |  |  |  |  |  |
| 1996 | 1.6.4.1.1.1 | Draft Non-SIT S&A Test Approach and Plan |  | 50d | 2023-12-18 A | 2024-02-23 A |  | 100% |  | 2023-12-18 | 2024-02-23 | 50d |  |  | finish no earlier than 2024-02-23 |  | Non-SIT S&A QT Test Team | Non-SIT S&A QT Test Team | S&A Qualification |  | 5.24 | Laura Kennedy | Complete | COMPLETE |  |  |  |
| 1997 | 1.6.4.1.1.2 | Internal Review of Non-SIT S&A Test Approach and Plan (Code Bodies and MHHSP) |  | 10d | 2024-02-26 A | 2024-03-08 A | 1996 | 100% |  | 2024-02-26 | 2024-03-08 | 10d |  |  |  |  | Code Bodies, SI Team, SRO | Code Bodies, SI Team, SRO | S&A Qualification |  | 5.24 | Laura Kennedy | Complete | COMPLETE |  |  |  |
| 1998 | 1.6.4.1.1.3 | Issue Non-SIT S&A Test Approach and Plan for Consultation |  | 15d | 2024-03-18 A | 2024-04-05 A | 1997 | 100% |  | 2024-03-18 | 2024-04-05 | 15d |  |  | start no earlier than 2024-03-18 |  | Participants | Participants | S&A Qualification |  | 5.24 | Laura Kennedy | Complete | COMPLETE |  |  |  |
| 1999 | 1.6.4.1.1.4 | Update Non-SIT S&A Test Approach and Plan Post-Consultation |  | 10d | 2024-04-08 A | 2024-04-19 A | 1998 | 100% |  | 2024-04-08 | 2024-04-19 | 10d |  |  |  |  | Non-SIT S&A QT Test Team | Non-SIT S&A QT Test Team | S&A Qualification |  | 5.24 | Laura Kennedy | Complete | COMPLETE |  |  |  |
| 2000 | 1.6.4.1.1.5 | QWG Endorsement of Non-SIT S&A Test Approach and Plan |  | 1d | 2024-05-14 A | 2024-05-14 A |  | 100% |  | 2024-05-14 | 2024-05-14 | 1d |  |  | finish no earlier than 2024-05-14 |  | Non-SIT S&A QT Test Team | Non-SIT S&A QT Test Team | S&A Qualification |  | 5.24 | Laura Kennedy | Complete | COMPLETE |  |  |  |
| 2001 | 1.6.4.1.1.6 | QAG Approval of Non-SIT S&A Test Approach and Plan | milestone | 0d | 2024-05-23 A | 2024-05-23 A | 2000FS+7d | 100% |  | 2024-05-23 | 2024-05-23 | 0d |  |  |  |  | Non-SIT S&A QT Test Team | Non-SIT S&A QT Test Team | S&A Qualification |  | 5.25 | Laura Kennedy | Complete | COMPLETE | T3-QU-0089 | QAG | T3 |
| 2002 | 1.6.4.1.1.7 | BSC & REC PAB Approval of Non-SIT S&A Test Approach and Plan | milestone | 0d | 2024-05-30 A | 2024-05-30 A | 2001FS+5d | 100% |  | 2024-05-30 | 2024-05-30 | 0d |  |  |  |  | Code Bodies | Code Bodies | S&A Qualification |  | 5.25 | Laura Kennedy | Complete | COMPLETE | T3-QU-0090 | QAG | T3 |

| ID | WBS | Task | Type | Duration | Start | Finish | Predecessors | Complete | Remaining | Baseline start | Baseline finish | Baseline duration | Total slack | Free slack | Constraint | Baseline cost | Responsible | Involved | Text9 | Task Status | Update Version | MHHS Resource Name | Sched Status | RAG | Milestone ID | Text29 | Tier |
| --- | --- | --- | --- | --- | --- | --- | --- | --- | --- | --- | --- | --- | --- | --- | --- | --- | --- | --- | --- | --- | --- | --- | --- | --- | --- | --- | --- |
| 2003 | 1.6.4.1.2 | **QT Test Data Approach and Plan** |  | 64d | 2024-04-19 A | 2024-07-18 A |  | 100% |  | 2024-04-19 | 2024-07-18 | 64d |  |  |  | -0 | N/A | N/A | S&A Qualification | -133.67 | 5.24 | N/A |  |  |  |  |  |
| 2004 | 1.6.4.1.2.1 | QT Test Data Approach agreed as part of the Non-SIT Supplier and Agent Test Approach and Plan | milestone | 0d | 2024-04-19 A | 2024-04-19 A | 1999 | 100% |  | 2024-04-19 | 2024-04-19 | 0d |  |  |  |  | Non-SIT S&A QT Test Team, Participants | Non-SIT S&A QT Test Team, Participants | S&A Qualification |  | 5.24 | Laura Kennedy | Complete | COMPLETE |  |  |  |
| 2005 | 1.6.4.1.2.2 | Draft Test Data Approach and Plan for QT |  | 10d | 2024-05-06 A | 2024-05-17 A | 2004 | 100% |  | 2024-05-06 | 2024-05-17 | 10d |  |  |  |  | Non-SIT S&A QT Test Team | Non-SIT S&A QT Test Team | S&A Qualification |  | 5.24 | Laura Kennedy | Complete | COMPLETE |  |  |  |
| 2006 | 1.6.4.1.2.3 | Internal Review (Code Bodies and MHHSP) of QT Test Data Approach and Plan |  | 15d | 2024-05-20 A | 2024-06-07 A | 2005 | 100% |  | 2024-05-20 | 2024-06-07 | 10d |  |  |  |  | Code Bodies, SI Team, SRO | Code Bodies, SI Team, SRO | S&A Qualification |  | 5.24 | Laura Kennedy | Complete | COMPLETE |  |  |  |
| 2007 | 1.6.4.1.2.4 | Issue QT Test Data Approach and Plan for Industry Consultation |  | 10d | 2024-06-10 A | 2024-06-21 A | 2006 | 100% |  | 2024-06-10 | 2024-06-21 | 10d |  |  |  |  | Participants | Participants | S&A Qualification |  | 5.24 | Laura Kennedy | Complete | COMPLETE |  |  |  |
| 2008 | 1.6.4.1.2.5 | Update QT Test Approach and Plan Post Industry Consultation |  | 5d | 2024-06-24 A | 2024-06-28 A | 2007 | 100% |  | 2024-06-24 | 2024-06-28 | 10d |  |  |  |  | Non-SIT S&A QT Team | Non-SIT S&A QT Team | S&A Qualification |  | 5.24 | Laura Kennedy | Complete | COMPLETE |  |  |  |
| 2009 | 1.6.4.1.2.6 | QWG Endorsement of Test Data Approach and Plan |  | 1d | 2024-07-09 A | 2024-07-09 A | 2008FS+6d | 100% |  | 2024-07-09 | 2024-07-09 | 1d |  |  |  |  | Non-SIT S&A QT Test Team | Non-SIT S&A QT Test Team | S&A Qualification |  | 5.24 | Laura Kennedy | Complete | COMPLETE |  |  |  |
| 2010 | 1.6.4.1.2.7 | QAG Approval of QT Test Data Approach and Plan | milestone | 0d | 2024-07-18 A | 2024-07-18 A | 2009FS+7d | 100% |  | 2024-07-18 | 2024-07-18 | 0d |  |  |  |  | Non-SIT S&A QT Test Team | Non-SIT S&A QT Test Team | S&A Qualification |  | 5.29 | Laura Kennedy | Complete | COMPLETE | T3-QU-0091 | QAG | T3 |
| 2011 | 1.6.4.1.3 | **QT Functional Test Scenarios and Test Cases** |  | 59d | 2024-03-04 A | 2024-05-23 A |  | 100% |  | 2024-03-04 | 2024-05-23 | 59d |  |  |  | -0 | N/A | N/A | S&A Qualification | -133.67 | 5.24 | N/A |  |  |  |  |  |
| 2012 | 1.6.4.1.3.1 | Draft Test Scenarios and Test Case list - Batch 1 |  | 10d | 2024-03-04 A | 2024-03-15 A |  | 100% |  | 2024-03-04 | 2024-03-15 | 10d |  |  | finish no earlier than 2024-03-15 |  | Non-SIT S&A QT Test Team, Code Bodies | Non-SIT S&A QT Test Team, Code Bodies | S&A Qualification |  | 5.24 | Laura Kennedy | Complete | COMPLETE |  |  |  |
| 2013 | 1.6.4.1.3.2 | Issue Batch 1 for Consultation |  | 15d | 2024-03-18 A | 2024-04-05 A | 2012 | 100% |  | 2024-03-18 | 2024-04-05 | 15d |  |  | start no earlier than 2024-03-18 |  | Participants | Participants | S&A Qualification |  | 5.24 | Laura Kennedy | Complete | COMPLETE |  |  |  |
| 2014 | 1.6.4.1.3.3 | Gap analysis against QT Requirements |  | 8d | 2024-03-18 A | 2024-03-27 A | 2012 | 100% |  | 2024-03-18 | 2024-03-27 | 8d |  |  |  |  | Non-SIT S&A QT Test Team | Non-SIT S&A QT Test Team | S&A Qualification |  | 5.24 | Laura Kennedy | Complete | COMPLETE |  |  |  |
| 2015 | 1.6.4.1.3.4 | Update Test Scenarios and Test Case list - Batch 2 |  | 6d | 2024-03-28 A | 2024-04-04 A | 2014 | 100% |  | 2024-03-28 | 2024-04-04 | 6d |  |  |  |  | Non-SIT S&A QT Test Team, Code Bodies | Non-SIT S&A QT Test Team, Code Bodies | S&A Qualification |  | 5.24 | Laura Kennedy | Complete | COMPLETE |  |  |  |
| 2016 | 1.6.4.1.3.5 | Issue Batch 2 for consultation |  | 10d | 2024-04-05 A | 2024-04-18 A | 2015 | 100% |  | 2024-04-05 | 2024-04-18 | 10d |  |  |  |  | Participants | Participants | S&A Qualification |  | 5.24 | Laura Kennedy | Complete | COMPLETE |  |  |  |
| 2017 | 1.6.4.1.3.6 | Update Batch 2 post consultation |  | 10d | 2024-04-19 A | 2024-05-02 A | 2016 | 100% |  | 2024-04-19 | 2024-05-02 | 10d |  |  |  |  | Non-SIT S&A QT Test Team, Code Bodies | Non-SIT S&A QT Test Team, Code Bodies | S&A Qualification |  | 5.24 | Laura Kennedy | Complete | COMPLETE |  |  |  |
| 2018 | 1.6.4.1.3.7 | QWG Endorsement of Batch 1 and 2 |  | 1d | 2024-05-14 A | 2024-05-14 A |  | 100% |  | 2024-05-14 | 2024-05-14 | 1d |  |  | finish no earlier than 2024-05-14 |  | Non-SIT S&A QT Test Team | Non-SIT S&A QT Test Team, Code Bodies, Participants | S&A Qualification |  | 5.24 | Laura Kennedy | Complete | COMPLETE |  |  |  |
| 2019 | 1.6.4.1.3.8 | QAG Approval of QT Functional Test Scenarios and Test Cases Batches 1 and 2 | milestone | 0d | 2024-05-23 A | 2024-05-23 A | 2018FS+7d | 100% |  | 2024-05-23 | 2024-05-23 | 0d |  |  |  |  | Non-SIT S&A QT Test Team | Non-SIT S&A QT Test Team, Code Bodies, Participants | S&A Qualification |  | 5.25 | Laura Kennedy | Complete | COMPLETE | T3-QU-0092 | QAG | T3 |
| 2020 | 1.6.4.1.4 | **QT Migration Test Scenarios and Test Cases** |  | 54d | 2024-05-06 A | 2024-07-18 A |  | 100% |  | 2024-05-06 | 2024-07-18 | 54d |  |  |  |  | N/A | N/A | S&A Qualification |  | 5.25 | N/A |  |  |  |  |  |
| 2021 | 1.6.4.1.4.1 | Draft Test Scenarios and Test Case list - Batch 1 |  | 20d | 2024-05-06 A | 2024-05-31 A | 995FS+12d | 100% |  | 2024-05-06 | 2024-05-31 | 20d |  |  |  |  | Non-SIT S&A QT Test Team, Code Bodies | Non-SIT S&A QT Test Team, Code Bodies | S&A Qualification |  | 5.25 | Laura Kennedy | Complete | COMPLETE |  |  |  |
| 2022 | 1.6.4.1.4.2 | Issue Batch 1 for Consultation |  | 10d | 2024-06-03 A | 2024-06-14 A | 2021 | 100% |  | 2024-06-03 | 2024-06-14 | 10d |  |  |  |  | Participants | Participants | S&A Qualification |  | 5.25 | Laura Kennedy | Complete | COMPLETE |  |  |  |
| 2023 | 1.6.4.1.4.3 | Update Batch 1 Post Consultation |  | 10d | 2024-06-17 A | 2024-06-28 A | 2022 | 100% |  | 2024-06-17 | 2024-06-28 | 10d |  |  |  |  | Non-SIT S&A QT Test Team | Non-SIT S&A QT Test Team | S&A Qualification |  | 5.25 | Laura Kennedy | Complete | COMPLETE |  |  |  |
| 2024 | 1.6.4.1.4.4 | QWG Endorsement of Batch 1 | milestone | 0d | 2024-07-09 A | 2024-07-09 A | 2023FS+7d | 100% |  | 2024-07-09 | 2024-07-09 | 0d |  |  |  |  | Non-SIT S&A QT Test Team | Non-SIT S&A QT Test Team, Code Bodies, Participants | S&A Qualification |  | 5.25 | Laura Kennedy | Complete | COMPLETE |  |  |  |
| 2025 | 1.6.4.1.4.5 | QAG Approval of QT Migration Test Scenarios and Test Cases Batches 1 | milestone | 0d | 2024-07-18 A | 2024-07-18 A | 2024FS+7d | 100% |  | 2024-07-18 | 2024-07-18 | 0d |  |  |  |  | Non-SIT S&A QT Test Team | Non-SIT S&A QT Test Team, Code Bodies, Participants | S&A Qualification |  | 5.29 | Laura Kennedy | Complete | COMPLETE | T3-QU-0119 | QAG | T3 |
| 2026 | 1.6.4.1.5 | **QT Functional (inc NF and Operational) Test Scenarios and Test Cases** |  | 63d | 2024-11-05 A | 2025-01-30 |  | 40% | 37.8d | 2024-11-04 | 2024-12-27 | 0d | 32309d |  |  |  | Non-SIT S&A QT Test Team |  | S&A Qualification | -721.67 |  | Laura Kennedy |  |  |  |  |  |
| 2027 | 1.6.4.1.5.1 | Draft Test Scenarios and Test Case list - Batch 3 |  | 20d | 2024-11-05 A | 2024-12-02 A | 882FS-1d | 100% |  | 2024-11-05 | 2024-12-02 | 0d |  |  |  |  | Non-SIT S&A QT Test Team |  | S&A Qualification |  | 6.11 | Laura Kennedy | Complete | COMPLETE |  |  |  |
| 2028 | 1.6.4.1.5.2 | Issue Batch 3 for Consultation |  | 10d | 2024-12-03 | 2024-12-16 | 2027 |  |  | 2024-12-03 | 2024-12-16 | 0d | 32309d | 0d |  |  | Non-SIT S&A QT Test Team |  | S&A Qualification | -16.67 | 6.11 | Laura Kennedy | Green | RED |  |  |  |
| 2029 | 1.6.4.1.5.3 | Update Batch 3 Post Consultation |  | 20d | 2024-12-17 | 2025-01-13 | 2028 |  |  | 2024-12-17 | 2025-01-13 | 0d | 32309d | 0d |  |  | Non-SIT S&A QT Test Team |  | S&A Qualification | -2.67 | 6.11 | Laura Kennedy | Green | RED |  |  |  |
| 2030 | 1.6.4.1.5.4 | QWG Endorsement of Batch 3 | milestone | 0d | 2025-01-22 | 2025-01-22 | 2029FS+7d |  |  | 2025-01-22 | 2025-01-22 | 0d | 32309d | 0d |  |  | Non-SIT S&A QT Test Team |  | S&A Qualification | 33.71 | 6.11 | Laura Kennedy | Green | RED |  |  |  |
| 2031 | 1.6.4.1.5.5 | QAG Approval of QT Functional Test Scenarios and Test Cases Batches 3 | milestone | 0d | 2025-01-30 | 2025-01-30 | 2030FS+6d |  |  | 2025-01-30 | 2025-01-30 | 0d | 32309d | 1d |  |  | Non-SIT S&A QT Test Team |  | S&A Qualification | 41.71 | 6.11 | Laura Kennedy | Green | RED | T3-QU-0123 | QAG | T3 |

Notes:
- 2027: 11/12/24 - Some final test cases being added to the Functional RTTM, which has delayed start, but this is expected to be resolved soon.
- 2028: 17/12/24 - This will be published on 18/12/24 and close on 15/01/24, delay caused by test cases being added to the RTTM, postponing the previous activity.
- 2029: 17/12/24 - This will now take place in Feb due to consultation going out late.
- 2030: 17/12/24 - This will now take place in Feb due to consultation going out late.
- 2031: 11/12/24 - Expected that QAG approval will place in February. This is because drafting of test cases is behind schedule due to dependency on SIT RTTM which is still adding additional test cases.

| ID | WBS | Task | Duration | Start | Finish | Predecessors | Complete | Remaining | Baseline start | Baseline finish | Baseline duration | Total slack | Free slack | Constraint | Responsible | Text9 | Task Status | Update Version | Sched Status | MHHS Resource Name | RAG |
| --- | --- | --- | --- | --- | --- | --- | --- | --- | --- | --- | --- | --- | --- | --- | --- | --- | --- | --- | --- | --- | --- |
| 2032 | 1.6.4.1.6 | **Qualification Testing Framework (Test Stubs and Supporting UI)** | 509d? | 2024-01-29 A | 2026-01-08 |  | 74% | 133.34d? | 2024-01-29 | 2026-01-08 | 0d | 32083d |  |  | Non-SIT S&A QT Test Team | S&A Qualification | -742.67 | 6.12 | Overdue Start | Laura Kennedy |  |
| 2033 | 1.6.4.1.6.1 | Proof of Concept for QTF Completion | 45d | 2024-01-29 A | 2024-03-29 A |  | 100% |  | 2024-01-29 | 2024-03-29 | 0d |  |  | finish no earlier than 2024-03-29 | Non-SIT S&A QT Test Team | S&A Qualification |  | 6.12 | Complete | Laura Kennedy | COMPLETE |
| 2034 | 1.6.4.1.6.2 | Discovery and Mobilisation | 25d | 2024-04-01 A | 2024-05-03 A | 2033 | 100% |  | 2024-04-01 | 2024-05-03 | 0d |  |  | finish no earlier than 2024-05-03 | Non-SIT S&A QT Test Team | S&A Qualification |  | 6.12 | Complete | Laura Kennedy | COMPLETE |
| 2035 | 1.6.4.1.6.3 | **Agile DBT of Qualification Testing Framework** | 83d | 2024-04-24 A | 2024-08-16 A |  | 100% |  | 2024-04-24 | 2024-08-16 | 0d |  |  |  | Non-SIT S&A QT Test Team | S&A Qualification | -742.67 | 6.12 | Overdue Start | Laura Kennedy |  |
| 2036 | 1.6.4.1.6.3.1 | **User Interface (UI)** | 48d | 2024-04-24 A | 2024-06-28 A |  | 100% |  | 2024-04-24 | 2024-06-28 | 0d |  |  |  | Non-SIT S&A QT Test Team | S&A Qualification | -742.67 | 6.12 | Overdue Start | Laura Kennedy |  |
| 2037 | 1.6.4.1.6.3.1.1 | UI Wireframe | 48d | 2024-04-24 A | 2024-06-28 A |  | 100% |  | 2024-04-24 | 2024-06-28 | 0d |  |  | finish no earlier than 2024-06-28 | Non-SIT S&A QT Test Team | S&A Qualification |  | 6.12 | Complete | Laura Kennedy | COMPLETE |
| 2038 | 1.6.4.1.6.3.1.2 | UI Standards | 35d | 2024-05-13 A | 2024-06-28 A | 2037FS+13d | 100% |  | 2024-05-13 | 2024-06-28 | 0d |  |  | finish no earlier than 2024-06-28 | Non-SIT S&A QT Test Team | S&A Qualification |  | 6.12 | Complete | Laura Kennedy | COMPLETE |
| 2039 | 1.6.4.1.6.3.1.3 | Elexon Branding Sylesheet | 2d | 2024-05-17 A | 2024-05-20 A | 2038FS+10d | 100% |  | 2024-05-17 | 2024-05-20 | 0d |  |  | finish no earlier than 2024-05-20 | Non-SIT S&A QT Test Team | S&A Qualification |  | 6.12 | Complete | Laura Kennedy | COMPLETE |
| 2040 | 1.6.4.1.6.3.1.4 | Elexon Branding QTF Logo | 2d | 2024-05-31 A | 2024-06-03 A | 2039FS+20d | 100% |  | 2024-05-31 | 2024-06-03 | 0d |  |  | finish no earlier than 2024-06-03 | Non-SIT S&A QT Test Team | S&A Qualification |  | 6.12 | Complete | Laura Kennedy | COMPLETE |
| 2041 | 1.6.4.1.6.3.2 | **Design, Build, Test** | 70d | 2024-05-13 A | 2024-08-16 A |  | 100% |  | 2024-05-13 | 2024-08-16 | 0d |  |  |  | Non-SIT S&A QT Test Team | S&A Qualification | -742.67 | 6.12 | Overdue Start | Laura Kennedy |  |
| 2042 | 1.6.4.1.6.3.2.1 | Core UI Screens | 60d | 2024-05-13 A | 2024-08-02 A | 2038SS | 100% |  | 2024-05-13 | 2024-08-02 | 0d |  |  | finish no earlier than 2024-08-02 | Non-SIT S&A QT Test Team | S&A Qualification |  | 6.12 | Complete | Laura Kennedy | COMPLETE |
| 2043 | 1.6.4.1.6.3.2.2 | Tooling (Trigger Files / Template Generators) | 70d | 2024-05-13 A | 2024-08-16 A | 2037SS+13d | 100% |  | 2024-05-13 | 2024-08-16 | 0d |  |  | finish no earlier than 2024-08-16 | Non-SIT S&A QT Test Team | S&A Qualification |  | 6.12 | Complete | Laura Kennedy | COMPLETE |
| 2044 | 1.6.4.1.6.3.2.3 | Database Schema | 50d | 2024-05-13 A | 2024-07-19 A | 2037SS+13d | 100% |  | 2024-05-13 | 2024-07-19 | 0d |  |  | finish no earlier than 2024-07-19 | Non-SIT S&A QT Test Team | S&A Qualification |  | 6.12 | Complete | Laura Kennedy | COMPLETE |
| 2045 | 1.6.4.1.6.3.2.4 | Core API's | 60d | 2024-05-13 A | 2024-08-02 A | 2037SS+13d | 100% |  | 2024-05-13 | 2024-08-02 | 0d |  |  | finish no earlier than 2024-08-02 | Non-SIT S&A QT Test Team | S&A Qualification |  | 6.12 | Complete | Laura Kennedy | COMPLETE |
| 2046 | 1.6.4.1.6.4 | QTF Test Cases DBT Refinement, Execution and Results Validation, Defect Management, Error Handling | 64d | 2024-11-05 A | 2025-01-31 | 2031FF, 2025FF, 2027SS | 30% | 44.8d | 2024-11-05 | 2025-01-31 | 0d | 32308d | 0d |  | Non-SIT S&A QT Test Team | S&A Qualification |  | 6.12 | Green | Laura Kennedy | GREEN |
| 2047 | 1.6.4.1.6.5 | **Environments** | 339d | 2024-04-15 A | 2025-07-31 |  | 98% | 7.06d | 2024-04-15 | 2025-07-31 | 0d | 32198d |  |  | Non-SIT S&A QT Test Team | S&A Qualification | -742.67 | 6.12 | Overdue Start | Laura Kennedy |  |
| 2048 | 1.6.4.1.6.5.1 | **Azure Devops** | 173d | 2024-04-15 A | 2024-12-11 A |  | 100% |  | 2024-04-15 | 2024-12-11 | 0d |  |  |  | Non-SIT S&A QT Test Team | S&A Qualification | -742.67 | 6.12 | Overdue Start | Laura Kennedy |  |
| 2049 | 1.6.4.1.6.5.1.1 | **QFT ADO Development Instance** | 15d | 2024-04-15 A | 2024-05-03 A |  | 100% |  | 2024-04-15 | 2024-05-03 | 0d |  |  |  | Non-SIT S&A QT Test Team | S&A Qualification | -742.67 | 6.12 | Overdue Start | Laura Kennedy |  |
| 2050 | 1.6.4.1.6.5.1.1.1 | Elexon Instance Setup for QTF Build | 5d | 2024-04-15 A | 2024-04-19 A | 2034SS+10d | 100% |  | 2024-04-15 | 2024-04-19 | 0d |  |  | finish no earlier than 2024-04-19 | Non-SIT S&A QT Test Team | S&A Qualification |  | 6.12 | Complete | Laura Kennedy | COMPLETE |
| 2051 | 1.6.4.1.6.5.1.1.2 | Configuration and User Access | 10d | 2024-04-22 A | 2024-05-03 A | 2050 | 100% |  | 2024-04-22 | 2024-05-03 | 0d |  |  | finish no earlier than 2024-05-03 | Non-SIT S&A QT Test Team | S&A Qualification |  | 6.12 | Complete | Laura Kennedy | COMPLETE |
| 2052 | 1.6.4.1.6.5.1.2 | **MHHSP ADO Instance** | 102d | 2024-07-23 A | 2024-12-11 A |  | 100% |  | 2024-07-23 | 2024-12-11 | 0d |  |  |  | Non-SIT S&A QT Test Team | S&A Qualification | -742.67 | 6.12 | Overdue Start | Laura Kennedy |  |
| 2053 | 1.6.4.1.6.5.1.2.1 | MHHSP Instance Setup for QTF Production | 29d | 2024-07-23 A | 2024-08-30 A | 2059SS+41d | 100% |  | 2024-07-23 | 2024-08-30 | 0d |  |  | finish no earlier than 2024-08-30 | Non-SIT S&A QT Test Team | S&A Qualification |  | 6.12 | Complete | Laura Kennedy | COMPLETE |
| 2054 | 1.6.4.1.6.5.1.2.2 | Configuration and User Access | 73d | 2024-09-02 A | 2024-12-11 A | 2053 | 100% |  | 2024-09-02 | 2024-12-11 | 0d |  |  | finish no earlier than 2024-09-27 | Non-SIT S&A QT Test Team | S&A Qualification |  | 6.12 | Complete | Laura Kennedy | COMPLETE |
| 2055 | 1.6.4.1.6.5.2 | **Temporary Development Environment** | 35d | 2024-04-15 A | 2024-05-31 A |  | 100% |  | 2024-04-15 | 2024-05-31 | 0d |  |  |  | Non-SIT S&A QT Test Team | S&A Qualification | -742.67 | 6.12 | Overdue Start | Laura Kennedy |  |
| 2056 | 1.6.4.1.6.5.2.1 | Design | 15d | 2024-04-15 A | 2024-05-03 A | 2034SS+10d | 100% |  | 2024-04-15 | 2024-05-03 | 0d |  |  | finish no earlier than 2024-05-03 | Non-SIT S&A QT Test Team | S&A Qualification |  | 6.12 | Complete | Laura Kennedy | COMPLETE |
| 2057 | 1.6.4.1.6.5.2.2 | Build and Deployment | 20d | 2024-05-06 A | 2024-05-31 A | 2051, 2056 | 100% |  | 2024-05-06 | 2024-05-31 | 0d |  |  | finish no earlier than 2024-05-31 | Non-SIT S&A QT Test Team | S&A Qualification |  | 6.12 | Complete | Laura Kennedy | COMPLETE |

Notes:
- 2032: 05/12/24 - Some final test cases being added to the Functional RTTM, which has delayed the start of 'Draft Test Scenarios and Test Case list - Batch 3', but this is expected to be resolved soon, hence why status of this activity is Amber.

| ID | WBS | Task | Duration | Start | Finish | Predecessors | Complete | Baseline start | Baseline finish | Baseline duration | Total slack | Free slack | Constraint | Responsible | Text9 | Task Status | Update Version | Sched Status | MHHS Resource Name | RAG |
| --- | --- | --- | --- | --- | --- | --- | --- | --- | --- | --- | --- | --- | --- | --- | --- | --- | --- | --- | --- | --- |
| 2058 | 1.6.4.1.6.5.3 | **Dev, Test & Prod Environment Requirements + Design** | 135d | 2024-05-27 A | 2024-11-29 A |  | 100% | 2024-05-27 | 2024-11-29 | 0d |  |  |  | Non-SIT S&A QT Test Team | S&A Qualification | -742.67 | 6.12 | Overdue Start | Laura Kennedy |  |
| 2059 | 1.6.4.1.6.5.3.1 | Design (including Security Review) | 135d | 2024-05-27 A | 2024-11-29 A | 2034FS+15d | 100% | 2024-05-27 | 2024-11-29 | 0d |  |  | finish no earlier than 2024-08-30 | Non-SIT S&A QT Test Team | S&A Qualification |  | 6.12 | Complete | Laura Kennedy | COMPLETE |
| 2060 | 1.6.4.1.6.5.3.2 | Hub Development Dev/Test | 20d | 2024-06-10 A | 2024-07-05 A | 2059SS+10d | 100% | 2024-06-10 | 2024-07-05 | 0d |  |  |  | Non-SIT S&A QT Test Team | S&A Qualification |  | 6.12 | Complete | Laura Kennedy | COMPLETE |
| 2061 | 1.6.4.1.6.5.3.3 | Hub Deployment | 20d | 2024-06-10 A | 2024-07-05 A | 2059FS+10d, 2060 | 100% | 2024-06-10 | 2024-07-05 | 0d |  |  | finish no earlier than 2024-07-05 | Non-SIT S&A QT Test Team | S&A Qualification |  | 6.12 | Complete | Laura Kennedy | COMPLETE |
| 2062 | 1.6.4.1.6.5.3.4 | Development Envn. Deployment | 53.8d | 2024-07-08 A | 2024-09-19 A | 2061 | 100% | 2024-07-08 | 2024-09-19 | 0d |  |  | finish no earlier than 2024-08-30 | Non-SIT S&A QT Test Team | S&A Qualification |  | 6.12 | Complete | Laura Kennedy | COMPLETE |
| 2063 | 1.6.4.1.6.5.3.5 | Test Envn. Deployment | 10d | 2024-09-19 A | 2024-10-03 A | 2062 | 100% | 2024-09-19 | 2024-10-03 | 0d |  |  | finish no earlier than 2024-09-13 | Non-SIT S&A QT Test Team | S&A Qualification |  | 6.12 | Complete | Laura Kennedy | COMPLETE |
| 2064 | 1.6.4.1.6.5.3.6 | Production Envn. Deployment | 25d | 2024-10-03 A | 2024-11-07 A | 2063 | 100% | 2024-10-03 | 2024-11-07 | 0d |  |  | finish no earlier than 2024-10-18 | Non-SIT S&A QT Test Team | S&A Qualification |  | 6.12 | Complete | Laura Kennedy | COMPLETE |
| 2065 | 1.6.4.1.6.5.4 | **QTF Deployment into Production** | 19d | 2025-02-03 | 2025-02-27 |  |  | 2025-02-03 | 2025-04-25 | 0d | 32308d |  |  | Non-SIT S&A QT Test Team | S&A Qualification | -742.67 | 6.15 | Overdue Start | Laura Kennedy |  |
| 2066 | 1.6.4.1.6.5.4.1 | App Deployment | 5d | 2025-02-03 | 2025-02-07 | 2046, 2064 |  | 2025-02-03 | 2025-04-25 | 0d | 32308d | 0d | start no earlier than 2025-02-03 | Non-SIT S&A QT Test Team | S&A Qualification | 45.33 | 6.15 | Green | Laura Kennedy | GREEN |
| 2067 | 1.6.4.1.6.5.4.2 | Smoke Test | 2d | 2025-02-10 | 2025-02-11 | 2066 |  | 2025-02-03 | 2025-02-04 | 0d | 32308d | 0d | finish no earlier than 2025-02-04 | Non-SIT S&A QT Test Team | S&A Qualification | 52.33 | 6.15 | yellow | Laura Kennedy | RED |
| 2068 | 1.6.4.1.6.5.4.3 | PEN Test | 2d | 2025-02-12 | 2025-02-13 | 2067 |  | 2025-02-05 | 2025-02-06 | 0d | 32308d | 0d | finish no earlier than 2025-02-06 | Non-SIT S&A QT Test Team | S&A Qualification | 54.33 | 6.15 | yellow | Laura Kennedy | RED |
| 2069 | 1.6.4.1.6.5.4.4 | Regression Test | 10d | 2025-02-14 | 2025-02-27 | 2068 |  | 2025-02-07 | 2025-02-20 | 0d | 32308d |  | finish no earlier than 2025-02-20 | Non-SIT S&A QT Test Team | S&A Qualification | 56.33 | 6.15 | yellow | Laura Kennedy | RED |
| 2070 | 1.6.4.1.6.5.5 | **DIP Onboarding (UIT)** | 101d | 2024-07-26 A | 2024-12-13 A |  | 100% | 2024-07-26 | 2024-11-29 | 0d |  |  |  | Non-SIT S&A QT Test Team | S&A Qualification | -742.67 | 6.15 | Overdue Start | Laura Kennedy |  |
| 2071 | 1.6.4.1.6.5.5.1 | DIP Simulator | 15d | 2024-07-26 A | 2024-08-15 A |  | 100% | 2024-07-26 | 2024-08-15 | 0d |  |  | finish no earlier than 2024-08-15 | Non-SIT S&A QT Test Team | S&A Qualification |  | 6.15 | Complete | Laura Kennedy | COMPLETE |
| 2072 | 1.6.4.1.6.5.5.2 | DIP (UIT) Instance available for Onboarding | 1d | 2024-08-05 A | 2024-08-05 A |  | 100% | 2024-08-05 | 2024-08-05 | 0d |  |  | start no earlier than 2024-08-05 | Non-SIT S&A QT Test Team | S&A Qualification |  | 6.15 | Complete | Laura Kennedy | COMPLETE |
| 2073 | 1.6.4.1.6.5.5.3 | DIP (UIT) Portal | 1d | 2024-09-03 A | 2024-09-03 A | 2072 | 100% | 2024-09-03 | 2024-09-03 | 0d |  |  | start no earlier than 2024-09-03 | Non-SIT S&A QT Test Team | S&A Qualification |  | 6.15 | Complete | Laura Kennedy | COMPLETE |
| 2074 | 1.6.4.1.6.5.5.4 | DIP (UIT) Onboarding for Development (incl. certificates and security compliance) | 39d | 2024-08-06 A | 2024-09-27 A | 2072 | 100% | 2024-08-06 | 2024-09-27 | 0d |  |  | finish no earlier than 2024-09-27 | Non-SIT S&A QT Test Team | S&A Qualification |  | 6.15 | Complete | Laura Kennedy | COMPLETE |
| 2075 | 1.6.4.1.6.5.5.5 | DIP (UIT) Onboarding for Development Connection Confirmed | 1d | 2024-09-30 A | 2024-09-30 A | 2074 | 100% | 2024-09-30 | 2024-09-30 | 0d |  |  | start no earlier than 2024-09-30 | Non-SIT S&A QT Test Team | S&A Qualification |  | 6.15 | Complete | Laura Kennedy | COMPLETE |
| 2076 | 1.6.4.1.6.5.5.6 | DIP (UIT) Onboarding for Test (incl. certificates and security compliance) | 5d | 2024-10-01 A | 2024-10-07 A | 2075 | 100% | 2024-10-01 | 2024-10-07 | 0d |  |  | finish no earlier than 2024-10-07 | Non-SIT S&A QT Test Team | S&A Qualification |  | 6.15 | Complete | Laura Kennedy | COMPLETE |
| 2077 | 1.6.4.1.6.5.5.7 | DIP (UIT) Onboarding for Test Connection Confirmed | 1d | 2024-10-08 A | 2024-10-08 A | 2076 | 100% | 2024-10-08 | 2024-10-08 | 0d |  |  | start no earlier than 2024-10-08 | Non-SIT S&A QT Test Team | S&A Qualification |  | 6.15 | Complete | Laura Kennedy | COMPLETE |
| 2078 | 1.6.4.1.6.5.5.8 | DIP (UIT) Onboarding for Prod (incl. certificates and security compliance) | 5d | 2024-10-09 A | 2024-10-15 A | 2077 | 100% | 2024-10-09 | 2024-10-15 | 0d |  |  | finish no earlier than 2024-10-15 | Non-SIT S&A QT Test Team | S&A Qualification |  | 6.15 | Complete | Laura Kennedy | COMPLETE |
| 2079 | 1.6.4.1.6.5.5.9 | DIP (UIT) Onboarding for Prod Connection Confirmed | 1d | 2024-10-16 A | 2024-10-16 A | 2078 | 100% | 2024-10-16 | 2024-10-16 | 0d |  |  | start no earlier than 2024-10-16 | Non-SIT S&A QT Test Team | S&A Qualification |  | 6.15 | Complete | Laura Kennedy | COMPLETE |
| 2080 | 1.6.4.1.6.5.5.10 | DIP UIT Test Stubs | 32d | 2024-10-31 A | 2024-12-13 A | 2075, 2077, 2079 | 100% | 2024-10-17 | 2024-11-29 | 0d |  |  | start no earlier than 2024-10-31 | Non-SIT S&A QT Test Team | S&A Qualification |  | 6.15 | Complete | Laura Kennedy | COMPLETE |
| 2081 | 1.6.4.1.6.5.6 | **DTN Onboarding** | 115d | 2024-05-20 A | 2024-10-25 A |  | 100% | 2024-05-20 | 2024-10-25 | 0d |  |  |  | Non-SIT S&A QT Test Team | S&A Qualification | -742.67 | 6.15 | Overdue Start | Laura Kennedy |  |
| 2082 | 1.6.4.1.6.5.6.1 | DTN Request Raised for Onboarding | 25d | 2024-05-20 A | 2024-06-21 A |  | 100% | 2024-05-20 | 2024-06-21 | 0d |  |  | start no earlier than 2024-05-20 | Non-SIT S&A QT Test Team | S&A Qualification |  | 6.15 | Complete | Laura Kennedy | COMPLETE |
| 2083 | 1.6.4.1.6.5.6.2 | Setup, configuration of New Host and Test Flags | 5d | 2024-06-24 A | 2024-06-28 A | 2082 | 100% | 2024-06-24 | 2024-06-28 | 0d |  |  | start no earlier than 2024-06-24 | Non-SIT S&A QT Test Team | S&A Qualification |  | 6.15 | Complete | Laura Kennedy | COMPLETE |
| 2084 | 1.6.4.1.6.5.6.3 | New VPN Connection (Test) | 30d | 2024-08-05 A | 2024-09-13 A | 2083 | 100% | 2024-08-05 | 2024-09-13 | 0d |  |  | start no earlier than 2024-08-05 | Non-SIT S&A QT Test Team | S&A Qualification |  | 6.15 | Complete | Laura Kennedy | COMPLETE |
| 2085 | 1.6.4.1.6.5.6.4 | New VPN Connection (Prod) | 30d | 2024-09-16 A | 2024-10-25 A | 2084 | 100% | 2024-09-16 | 2024-10-25 | 0d |  |  | finish no earlier than 2024-10-25 | Non-SIT S&A QT Test Team | S&A Qualification |  | 6.15 | Complete | Laura Kennedy | COMPLETE |
| 2086 | 1.6.4.1.6.5.6.5 | DTN Test Stubs | 10d | 2024-09-16 A | 2024-09-27 A | 2084 | 100% | 2024-09-16 | 2024-09-27 | 0d |  |  | start no earlier than 2024-09-16 | Non-SIT S&A QT Test Team | S&A Qualification |  | 6.15 | Complete | Laura Kennedy | COMPLETE |

Notes:
- 2080: 12/11/24 - Additional time required to configure test stubs, forecast pushed out to reflect this.

| ID | WBS | Task | Type | Duration | Start | Finish | Predecessors | Complete | Remaining | Actual start | Actual finish | Baseline start | Baseline finish | Baseline duration | Constraint | Responsible | Text9 | Task Status | Update Version | Sched Status | MHHS Resource Name | RAG |
| --- | --- | --- | --- | --- | --- | --- | --- | --- | --- | --- | --- | --- | --- | --- | --- | --- | --- | --- | --- | --- | --- | --- |
| 2087 | 1.6.4.1.6.5.7 | **Generate Tooling** |  | 334d | 2024-04-22 A | 2025-07-31 |  | 100% |  |  | 2024-09-24 | 2024-04-22 | 2025-07-31 | 0d |  | Non-SIT S&A QT Test Team | S&A Qualification | -742.67 | 6.15 | Overdue Start | Laura Kennedy |  |
| 2088 | 1.6.4.1.6.5.7.1 | MPAN Core Generator |  | 25d | 2024-04-22 A | 2024-05-24 A |  | 100% |  |  |  | 2024-04-22 | 2024-05-24 | 0d | finish no earlier than 2024-05-24 | Non-SIT S&A QT Test Team | S&A Qualification |  | 6.15 | Complete | Laura Kennedy | COMPLETE |
| 2089 | 1.6.4.1.6.5.7.2 | MPAN File Generator |  | 55d | 2024-05-27 A | 2024-08-09 A | 2088 | 100% |  |  |  | 2024-05-27 | 2024-08-09 | 0d | finish no earlier than 2024-08-09 | Non-SIT S&A QT Test Team | S&A Qualification |  | 6.15 | Complete | Laura Kennedy | COMPLETE |
| 2090 | 1.6.4.1.6.5.7.3 | MPAN Template Loader |  | 32d | 2024-08-12 A | 2024-09-24 A | 2089 | 100% |  |  |  | 2024-08-12 | 2024-09-24 | 0d | finish no earlier than 2024-09-24 | Non-SIT S&A QT Test Team | S&A Qualification |  | 6.15 | Complete | Laura Kennedy | COMPLETE |
| 2091 | 1.6.4.1.6.5.7.4 | ADO Extract (QTC) From SIT |  | 30d | 2024-05-06 A | 2024-06-14 A |  | 100% |  |  |  | 2024-05-06 | 2024-06-14 | 0d | finish no earlier than 2024-06-14 | Non-SIT S&A QT Test Team | S&A Qualification |  | 6.15 | Complete | Laura Kennedy | COMPLETE |
| 2092 | 1.6.4.1.6.5.7.5 | Populate QT ADO |  | 40d | 2024-06-17 A | 2024-08-09 A | 2091 | 100% |  |  |  | 2024-06-17 | 2024-08-09 | 0d | finish no earlier than 2024-08-09 | Non-SIT S&A QT Test Team | S&A Qualification |  | 6.15 | Complete | Laura Kennedy | COMPLETE |
| 2093 | 1.6.4.1.6.5.7.6 | Create QTC Spreadsheets |  | 20d | 2024-06-03 A | 2024-06-28 A | 2091 | 100% |  |  |  | 2024-06-03 | 2024-06-28 | 0d | finish no earlier than 2024-06-28 | Non-SIT S&A QT Test Team | S&A Qualification |  | 6.15 | Complete | Laura Kennedy | COMPLETE |
| 2094 | 1.6.4.1.6.5.7.7 | Upload QTC Spreadsheets to QTF |  | 20d | 2024-07-01 A | 2024-07-26 A | 2093 | 100% |  |  |  | 2024-07-01 | 2024-07-26 | 0d | finish no earlier than 2024-07-26 | Non-SIT S&A QT Test Team | S&A Qualification |  | 6.15 | Complete | Laura Kennedy | COMPLETE |
| 2095 | 1.6.4.1.6.5.7.8 | Create QTC Set / Master QTC Loader |  | 40d | 2024-07-22 A | 2024-09-13 A | 2094 | 100% |  |  |  | 2024-07-22 | 2024-09-13 | 0d | finish no earlier than 2024-09-13 | Non-SIT S&A QT Test Team | S&A Qualification |  | 6.15 | Complete | Laura Kennedy | COMPLETE |
| 2096 | 1.6.4.1.6.5.8 | **Test Data** |  | 15d | 2024-06-10 A | 2024-06-28 A |  | 100% |  |  |  | 2024-06-10 | 2024-06-28 | 0d |  | Non-SIT S&A QT Test Team | S&A Qualification | -742.67 | 6.12 | Overdue Start | Laura Kennedy |  |
| 2097 | 1.6.4.1.6.5.8.1 | Sample MPAN Data + Attributes from Suppliers |  | 15d | 2024-06-10 A | 2024-06-28 A |  | 100% |  |  |  | 2024-06-10 | 2024-06-28 | 0d | finish no earlier than 2024-06-28 | Non-SIT S&A QT Test Team | S&A Qualification |  | 6.12 | Complete | Laura Kennedy | COMPLETE |
| 2098 | 1.6.4.1.6.6 | **MPANs, DIP Messages, Settlement, Consumption, Reference** |  | 423d? | 2024-05-27 A | 2026-01-07 |  | 45% | 231.47d? |  |  | 2024-05-27 | 2026-01-07 | 0d |  | Non-SIT S&A QT Test Team | S&A Qualification | -742.67 | 6.12 | Overdue Start | Laura Kennedy |  |
| 2099 | 1.6.4.1.6.6.1 | Create MPAN Data |  | 55d | 2024-05-27 A | 2024-08-09 A | 2088 | 100% |  |  |  | 2024-05-27 | 2024-08-09 | 0d | finish no earlier than 2024-08-09 | Non-SIT S&A QT Test Team | S&A Qualification |  | 6.12 | Complete | Laura Kennedy | COMPLETE |
| 2100 | 1.6.4.1.6.6.2 | Create message templates (DIP, CSS, DTN) |  | 40d | 2024-06-03 A | 2024-07-26 A |  | 100% |  |  |  | 2024-06-03 | 2024-07-26 | 0d | finish no earlier than 2024-07-26 | Non-SIT S&A QT Test Team | S&A Qualification |  | 6.12 | Complete | Laura Kennedy | COMPLETE |
| 2101 | 1.6.4.1.6.6.3 | Create Consumption Data Templates |  | 20d | 2024-09-16 A | 2024-10-11 A |  | 100% |  |  |  | 2024-09-16 | 2024-10-11 | 0d | finish no earlier than 2024-10-11 | Non-SIT S&A QT Test Team | S&A Qualification |  | 6.12 | Complete | Laura Kennedy | COMPLETE |
| 2102 | 1.6.4.1.6.6.4 | Load Consumption Data |  | 25d | 2024-11-11 A | 2024-12-13 A | 2101FS+20d | 100% |  |  |  | 2024-11-11 | 2024-12-06 | 0d |  | Non-SIT S&A QT Test Team | S&A Qualification |  | 6.12 | Complete | Laura Kennedy | COMPLETE |
| 2103 | 1.6.4.1.6.6.5 | Create Load Shape and Load Shape Total Templates |  | 20d | 2024-09-16 A | 2024-10-11 A |  | 100% |  |  |  | 2024-09-16 | 2024-10-11 | 0d | finish no earlier than 2024-10-11 | Non-SIT S&A QT Test Team | S&A Qualification |  | 6.12 | Complete | Laura Kennedy | COMPLETE |
| 2104 | 1.6.4.1.6.6.6 | Load Shape and Load Shape Total Data |  | 25d | 2024-11-11 A | 2024-12-13 A | 2103FS+20d | 100% |  |  |  | 2024-11-11 | 2024-12-06 | 0d |  | Non-SIT S&A QT Test Team | S&A Qualification |  | 6.12 | Complete | Laura Kennedy | COMPLETE |
| 2105 | 1.6.4.1.6.6.7 | Create Settlement Report Templates |  | 20d | 2024-09-16 A | 2024-10-11 A |  | 100% |  |  |  | 2024-09-16 | 2024-10-11 | 0d | finish no earlier than 2024-10-11 | Non-SIT S&A QT Test Team | S&A Qualification |  | 6.12 | Complete | Laura Kennedy | COMPLETE |
| 2106 | 1.6.4.1.6.6.8 | Load Settlement Report Data |  | 25d | 2024-11-11 A | 2024-12-13 A | 2105FS+20d | 100% |  |  |  | 2024-11-11 | 2024-12-06 | 0d |  | Non-SIT S&A QT Test Team | S&A Qualification |  | 6.12 | Complete | Laura Kennedy | COMPLETE |
| 2107 | 1.6.4.1.6.6.9 | Market Domain Data (MDD) For Legacy Systems |  | 25d | 2024-07-29 A | 2024-08-30 A |  | 100% |  |  |  | 2024-07-29 | 2024-08-30 | 0d | finish no earlier than 2024-08-30 | Non-SIT S&A QT Test Team | S&A Qualification |  | 6.12 | Complete | Laura Kennedy | COMPLETE |
| 2108 | 1.6.4.1.6.6.10 | **Industry Standing Data (ISD)** |  | 71d | 2024-07-26 | 2024-11-01 |  | 100% |  | 2024-06-10 | 2024-10-25 | 2024-07-26 | 2024-11-01 | 0d |  | Non-SIT S&A QT Test Team | S&A Qualification | -742.67 | 6.12 | Overdue Start | Laura Kennedy |  |
| 2109 | 1.6.4.1.6.6.10.1 | Dependant on Receiving ISD Agreed Source Data from Helix |  | 1d | 2024-08-23 A | 2024-08-23 A |  | 100% |  |  |  | 2024-08-23 | 2024-08-23 | 0d | finish no earlier than 2024-07-26 | Non-SIT S&A QT Test Team | S&A Qualification |  | 6.12 | Complete | Laura Kennedy | COMPLETE |
| 2110 | 1.6.4.1.6.6.10.2 | Helix Dev Environment migration |  | 6d | 2024-07-29 A | 2024-08-05 A |  | 100% |  |  |  | 2024-07-29 | 2024-08-05 | 0d | finish no earlier than 2024-08-05 | Non-SIT S&A QT Test Team | S&A Qualification |  | 6.12 | Complete | Laura Kennedy | COMPLETE |
| 2111 | 1.6.4.1.6.6.10.3 | STGi (UK) migration |  | 5d | 2024-09-09 A | 2024-09-13 A |  | 100% |  |  |  | 2024-09-09 | 2024-09-13 | 0d | finish no earlier than 2024-09-13 | Non-SIT S&A QT Test Team | S&A Qualification |  | 6.12 | Complete | Laura Kennedy | COMPLETE |
| 2112 | 1.6.4.1.6.6.10.4 | Maintenance window between cycle 2 and 3 | manual | 1d | 2024-09-20 A | 2024-09-20 A |  | 100% |  |  |  | 2024-09-20 | 2024-09-20 | 0d |  | Non-SIT S&A QT Test Team | S&A Qualification |  | 6.12 | Complete | Laura Kennedy | COMPLETE |
| 2113 | 1.6.4.1.6.6.10.5 | First View of Migrated ISD Data |  | 28d | 2024-08-21 A | 2024-09-27 A |  | 100% |  |  |  | 2024-08-21 | 2024-09-27 | 0d | finish no earlier than 2024-09-27 | Non-SIT S&A QT Test Team | S&A Qualification |  | 6.12 | Complete | Laura Kennedy | COMPLETE |
| 2114 | 1.6.4.1.6.6.10.6 | Second View of Migrated ISD Data (HXT1 (SIT B) migration) |  | 5d | 2024-09-23 A | 2024-09-27 A |  | 100% |  |  |  | 2024-09-23 | 2024-09-27 | 0d | start no earlier than 2024-09-23 | Non-SIT S&A QT Test Team | S&A Qualification |  | 6.12 | Complete | Laura Kennedy | COMPLETE |
| 2115 | 1.6.4.1.6.6.10.7 | Final Cycle 3 Migrated ISD Data |  | 5d | 2024-06-10 A | 2024-06-14 A |  | 100% |  |  |  | 2024-06-10 | 2024-06-14 | 0d |  | Non-SIT S&A QT Test Team | S&A Qualification |  | 6.12 | Complete | Laura Kennedy | COMPLETE |
| 2116 | 1.6.4.1.6.6.10.8 | Create ISD Template inc. DIP ID |  | 35d | 2024-06-10 A | 2024-07-26 A |  | 100% |  |  |  | 2024-06-10 | 2024-07-26 | 0d |  | Non-SIT S&A QT Test Team | S&A Qualification |  | 6.12 | Complete | Laura Kennedy | COMPLETE |
| 2117 | 1.6.4.1.6.6.10.9 | Publish Qualification ISD | manual | 10d | 2024-10-14 A | 2024-10-25 A |  | 100% |  |  |  | 2024-10-14 | 2024-10-25 | 0d |  | Non-SIT S&A QT Test Team | S&A Qualification |  | 6.12 | Complete | Laura Kennedy | COMPLETE |

| ID | WBS | Task | Duration | Start | Finish | Predecessors | Complete | Remaining | Baseline start | Baseline finish | Baseline duration | Total slack | Free slack | Constraint | Responsible | Text9 | Task Status | Update Version | Sched Status | MHHS Resource Name | RAG |
| --- | --- | --- | --- | --- | --- | --- | --- | --- | --- | --- | --- | --- | --- | --- | --- | --- | --- | --- | --- | --- | --- |
| 2118 | 1.6.4.1.6.6.11 | **Industry Standing Data (ISD)** | 71d? | 2024-07-26 A | 2024-11-01 A |  | 100% |  | 2024-07-26 | 2024-11-01 | 0d |  |  |  | Non-SIT S&A QT Test Team | S&A Qualification | -742.67 | 6.12 | Overdue Start | Laura Kennedy |  |
| 2119 | 1.6.4.1.6.6.11.1 | Dependant on Receiving ISD Agreed Source Data from Helix | 1d | 2024-07-26 A | 2024-07-26 A |  | 100% |  | 2024-07-26 | 2024-07-26 | 0d |  |  | start no earlier than 2024-07-26 | Non-SIT S&A QT Test Team | S&A Qualification |  | 6.12 | Complete | Laura Kennedy | COMPLETE |
| 2120 | 1.6.4.1.6.6.11.2 | Helix Dev Environment migration | 6d | 2024-07-29 A | 2024-08-05 A | 2119 | 100% |  | 2024-07-29 | 2024-08-05 | 0d |  |  | finish no earlier than 2024-08-05 | Non-SIT S&A QT Test Team | S&A Qualification |  | 6.12 | Complete | Laura Kennedy | COMPLETE |
| 2121 | 1.6.4.1.6.6.11.3 | STGi (UK) migration | 5d | 2024-09-09 A | 2024-09-13 A | 2119 | 100% |  | 2024-09-09 | 2024-09-13 | 0d |  |  | finish no earlier than 2024-09-13 | Non-SIT S&A QT Test Team | S&A Qualification |  | 6.12 | Complete | Laura Kennedy | COMPLETE |
| 2122 | 1.6.4.1.6.6.11.4 | Maintenance window between cycle 2 and 3 | 1d | 2024-09-20 A | 2024-09-20 A | 2119 | 100% |  | 2024-09-20 | 2024-09-20 | 0d |  |  | finish no earlier than 2024-09-20 | Non-SIT S&A QT Test Team | S&A Qualification |  | 6.12 | Complete | Laura Kennedy | COMPLETE |
| 2123 | 1.6.4.1.6.6.11.5 | First View of Migrated ISD Data | 5d | 2024-09-23 A | 2024-09-27 A | 2122 | 100% |  | 2024-09-23 | 2024-09-27 | 0d |  |  | finish no earlier than 2024-09-27 | Non-SIT S&A QT Test Team | S&A Qualification |  | 6.12 | Complete | Laura Kennedy | COMPLETE |
| 2124 | 1.6.4.1.6.6.11.6 | Second View of Migrated ISD Data (HXT1 (SIT B) migration) | 5d | 2024-09-23 A | 2024-09-27 A | 2122 | 100% |  | 2024-09-23 | 2024-09-27 | 0d |  |  | finish no earlier than 2024-09-27 | Non-SIT S&A QT Test Team | S&A Qualification |  | 6.12 | Complete | Laura Kennedy | COMPLETE |
| 2125 | 1.6.4.1.6.6.11.7 | Final Cycle 3 Migrated ISD Data | 5d | 2024-10-07 A | 2024-10-11 A | 2123 | 100% |  | 2024-10-07 | 2024-10-11 | 0d |  |  | finish no earlier than 2024-10-11 | Non-SIT S&A QT Test Team | S&A Qualification |  | 6.12 | Complete | Laura Kennedy | COMPLETE |
| 2126 | 1.6.4.1.6.6.11.8 | Create ISD Template inc. DIP ID | 35d? | 2024-09-16 A | 2024-11-01 A | 2122 | 100% |  | 2024-09-16 | 2024-11-01 | 0d |  |  | finish no earlier than 2024-11-01 | Non-SIT S&A QT Test Team | S&A Qualification |  | 6.12 | Complete | Laura Kennedy | COMPLETE |
| 2127 | 1.6.4.1.6.6.11.9 | Publish Qualification ISD | 10d? | 2024-10-14 A | 2024-10-25 A | 2125, 2122 | 100% |  | 2024-10-14 | 2024-10-25 | 0d |  |  | finish no earlier than 2024-10-25 | Non-SIT S&A QT Test Team | S&A Qualification |  | 6.12 | Complete | Laura Kennedy | COMPLETE |
| 2128 | 1.6.4.1.6.6.12 | **BETA Testing 1 - Test Data** | 27d | 2024-11-01 A | 2024-12-09 |  | 50% | 13.5d | 2024-11-01 | 2024-11-15 | 0d |  |  |  | Non-SIT S&A QT Test Team | S&A Qualification | -169.67 | 6.12 | Overdue Start | Laura Kennedy |  |
| 2129 | 1.6.4.1.6.6.12.1 | Provide Example MPAN File | 3d | 2024-11-01 A | 2024-11-05 A | 2172SS | 100% |  | 2024-11-01 | 2024-11-05 | 0d |  |  | finish no earlier than 2024-11-05 | Non-SIT S&A QT Test Team | S&A Qualification |  | 6.12 | Complete | Laura Kennedy | COMPLETE |
| 2130 | 1.6.4.1.6.6.12.2 | Load Example MPAN File | 6d | 2024-11-06 A | 2024-11-13 A | 2129 | 100% |  | 2024-11-06 | 2024-11-13 | 0d |  |  | finish no earlier than 2024-11-13 | Non-SIT S&A QT Test Team | S&A Qualification |  | 6.12 | Complete | Laura Kennedy | COMPLETE |
| 2131 | 1.6.4.1.6.6.12.3 | Industry Standing Data (ISD) | 6d | 2024-11-06 A | 2024-11-13 A | 2172SS+3d | 100% |  | 2024-11-06 | 2024-11-13 | 0d |  |  | finish no earlier than 2024-11-13 | Non-SIT S&A QT Test Team | S&A Qualification |  | 6.12 | Complete | Laura Kennedy | COMPLETE |
| 2132 | 1.6.4.1.6.6.12.4 | Market Domain Data (MDD) | 6d | 2024-11-06 A | 2024-11-13 A | 2172SS+3d | 100% |  | 2024-11-06 | 2024-11-13 | 0d |  |  | finish no earlier than 2024-11-13 | Non-SIT S&A QT Test Team | S&A Qualification |  | 6.12 | Complete | Laura Kennedy | COMPLETE |
| 2133 | 1.6.4.1.6.6.12.5 | Load ISD / MDD Data | 1d | 2024-12-06 A | 2024-12-06 A | 2131FS+16d, 2132FS+11d | 100% |  | 2024-11-14 | 2024-11-14 | 0d |  |  | start no earlier than 2024-11-14 | Non-SIT S&A QT Test Team | S&A Qualification |  | 6.12 | Complete | Laura Kennedy | COMPLETE |
| 2134 | 1.6.4.1.6.6.12.6 | Create QTC sets and Test MPANs via QTF | 1d | 2024-12-06 A | 2024-12-06 A | 2130FS+16d | 100% |  | 2024-11-14 | 2024-11-14 | 0d |  |  | start no earlier than 2024-11-14 | Non-SIT S&A QT Test Team | S&A Qualification |  | 6.12 | Complete | Laura Kennedy | COMPLETE |
| 2135 | 1.6.4.1.6.6.12.7 | Create QTC sets in ADO via QTF | 1d | 2024-12-06 A | 2024-12-06 A | 2134SS | 100% |  | 2024-11-14 | 2024-11-14 | 0d |  |  | start no earlier than 2024-11-14 | Non-SIT S&A QT Test Team | S&A Qualification |  | 6.12 | Complete | Laura Kennedy | COMPLETE |
| 2136 | 1.6.4.1.6.6.12.8 | Provide Test MPANs (Suppliers only) allocated to specfic QTC's | 1d | 2024-12-06 A | 2024-12-06 A | 2133SS | 100% |  | 2024-11-14 | 2024-11-14 | 0d |  |  | start no earlier than 2024-11-14 | Non-SIT S&A QT Test Team | S&A Qualification |  | 6.12 | Complete | Laura Kennedy | COMPLETE |
| 2137 | 1.6.4.1.6.6.12.9 | Load Test MPANs | 1d | 2024-12-09 A | 2024-12-09 A | 2136 | 100% |  | 2024-11-15 | 2024-11-15 | 0d |  |  | start no earlier than 2024-11-15 | Non-SIT S&A QT Test Team | S&A Qualification |  | 6.12 | Complete | Laura Kennedy | COMPLETE |
| 2138 | 1.6.4.1.6.6.12.10 | **BETA Testing 2 - Test Data** | 11d | 2025-01-08 | 2025-01-22 |  |  |  | 2025-01-08 | 2025-01-22 | 0d |  |  |  | Non-SIT S&A QT Test Team | S&A Qualification | -169.67 | 6.15 | green | Laura Kennedy |  |
| 2139 | 1.6.4.1.6.6.12.10.1 | Provide Example MPAN File | 3d | 2025-01-08 | 2025-01-10 | 2173SS |  |  | 2025-01-08 | 2025-01-10 | 0d | 32334d | 0d | start no earlier than 2025-01-08 | Non-SIT S&A QT Test Team | S&A Qualification | 19.33 | 6.15 | Green | Laura Kennedy | GREEN |
| 2140 | 1.6.4.1.6.6.12.10.2 | Load Example MPAN File | 6d | 2025-01-13 | 2025-01-20 | 2139 |  |  | 2025-01-13 | 2025-01-20 | 0d | 32334d | 0d | start no earlier than 2025-01-13 | Non-SIT S&A QT Test Team | S&A Qualification | 24.33 | 6.15 | Green | Laura Kennedy | GREEN |
| 2141 | 1.6.4.1.6.6.12.10.3 | Industry Standing Data (ISD) | 6d | 2025-01-08 | 2025-01-15 | 2127, 2173SS |  |  | 2025-01-08 | 2025-01-15 | 0d | 32338d | 0d | start no earlier than 2025-01-08 | Non-SIT S&A QT Test Team | S&A Qualification | 19.33 | 6.15 | Green | Laura Kennedy | GREEN |
| 2142 | 1.6.4.1.6.6.12.10.4 | Market Domain Data (MDD) | 6d | 2025-01-08 | 2025-01-15 | 2101, 2173SS |  |  | 2025-01-08 | 2025-01-15 | 0d | 32338d | 0d | start no earlier than 2025-01-08 | Non-SIT S&A QT Test Team | S&A Qualification | 19.33 | 6.15 | Green | Laura Kennedy | GREEN |
| 2143 | 1.6.4.1.6.6.12.10.5 | Load ISD / MDD Data | 1d | 2025-01-16 | 2025-01-16 | 2141, 2142, 2173SS |  |  | 2025-01-16 | 2025-01-16 | 0d | 32338d |  | start no earlier than 2025-01-16 | Non-SIT S&A QT Test Team | S&A Qualification | 27.33 | 6.15 | Green | Laura Kennedy | GREEN |
| 2144 | 1.6.4.1.6.6.12.10.6 | Create QTC sets and Test MPANs via QTF | 1d | 2025-01-21 | 2025-01-21 | 2140 |  |  | 2025-01-21 | 2025-01-21 | 0d | 32334d | 0d | start no earlier than 2025-01-21 | Non-SIT S&A QT Test Team | S&A Qualification | 32.33 | 6.15 | Green | Laura Kennedy | GREEN |
| 2145 | 1.6.4.1.6.6.12.10.7 | Create QTC sets in ADO via QTF | 1d | 2025-01-21 | 2025-01-21 | 2144SS |  |  | 2025-01-21 | 2025-01-21 | 0d | 32335d |  | start no earlier than 2025-01-21 | Non-SIT S&A QT Test Team | S&A Qualification | 32.33 | 6.15 | Green | Laura Kennedy | GREEN |
| 2146 | 1.6.4.1.6.6.12.10.8 | Provide Test MPANs (Suppliers only) allocated to specfic QTC's | 1d | 2025-01-21 | 2025-01-21 | 2144SS |  |  | 2025-01-21 | 2025-01-21 | 0d | 32334d | 0d | start no earlier than 2025-01-21 | Non-SIT S&A QT Test Team | S&A Qualification | 32.33 | 6.15 | Green | Laura Kennedy | GREEN |
| 2147 | 1.6.4.1.6.6.12.10.9 | Load Test MPANs | 1d | 2025-01-22 | 2025-01-22 | 2146 |  |  | 2025-01-22 | 2025-01-22 | 0d | 32334d |  | start no earlier than 2025-01-22 | Non-SIT S&A QT Test Team | S&A Qualification | 33.33 | 6.15 | Green | Laura Kennedy | GREEN |

Notes:
- 2138: 17/12/24 - Expanded QTF section has been included.
- 2139: 17/12/24 - Expanded QTF section has been included.
- 2140: 17/12/24 - Expanded QTF section has been included.
- 2141: 17/12/24 - Expanded QTF section has been included.
- 2142: 17/12/24 - Expanded QTF section has been included.
- 2143: 17/12/24 - Expanded QTF section has been included.
- 2144: 17/12/24 - Expanded QTF section has been included.
- 2145: 17/12/24 - Expanded QTF section has been included.
- 2146: 17/12/24 - Expanded QTF section has been included.
- 2147: 17/12/24 - Expanded QTF section has been included.

| ID | WBS | Task | Type | Duration | Start | Finish | Predecessors | Complete | Remaining | Baseline start | Baseline finish | Baseline duration | Total slack | Free slack | Constraint | Responsible | Text9 | Task Status | Update Version | Sched Status | MHHS Resource Name | RAG | Milestone ID | Tier |
| --- | --- | --- | --- | --- | --- | --- | --- | --- | --- | --- | --- | --- | --- | --- | --- | --- | --- | --- | --- | --- | --- | --- | --- | --- |
| 2148 | 1.6.4.1.6.6.13 | **Wave 1 Test Data** |  | 46d | 2025-05-12 | 2025-07-15 | 2134SS |  |  | 2025-05-12 | 2025-07-15 | 0d |  |  |  | Non-SIT S&A QT Test Team | S&A Qualification | -168.67 | 6.12 | Overdue Start | Laura Kennedy |  |  |  |
| 2149 | 1.6.4.1.6.6.13.1 | Test Data Request + Templates Completed |  | 16d | 2025-04-21 | 2025-05-12 | 2133SS |  |  | 2025-04-21 | 2025-05-12 | 0d | 32226d | 6d | finish no earlier than 2025-05-12 | Non-SIT S&A QT Test Team | S&A Qualification | 122.33 | 6.12 | Green | Laura Kennedy | GREEN |  |  |
| 2150 | 1.6.4.1.6.6.13.2 | Test Data Generated |  | 10d | 2025-05-21 | 2025-06-03 | 2136, 2149 |  |  | 2025-05-21 | 2025-06-03 | 0d | 32220d | 0d | finish no earlier than 2025-06-03 | Non-SIT S&A QT Test Team | S&A Qualification | 152.33 | 6.12 | Green | Laura Kennedy | GREEN |  |  |
| 2151 | 1.6.4.1.6.6.13.3 | Test Data Loaded into QP Systems |  | 20d | 2025-06-04 | 2025-07-01 | 2150 |  |  | 2025-06-04 | 2025-07-01 | 0d | 32220d |  | finish no earlier than 2025-06-17 | Non-SIT S&A QT Test Team | S&A Qualification | 166.33 | 6.12 | Green | Laura Kennedy | GREEN |  |  |
| 2152 | 1.6.4.1.6.6.13.4 | Test Data Loaded into QTF + ADO |  | 19d | 2025-06-04 | 2025-06-30 | 2150 |  |  | 2025-06-04 | 2025-06-30 | 0d | 32221d |  | finish no earlier than 2025-06-17 | Non-SIT S&A QT Test Team | S&A Qualification | 166.33 | 6.12 | Green | Laura Kennedy | GREEN |  |  |
| 2153 | 1.6.4.1.6.6.14 | **Wave 2 Test Data** |  | 42d | 2025-07-07 | 2025-09-03 |  |  |  | 2025-07-07 | 2025-09-03 | 0d |  |  |  | Non-SIT S&A QT Test Team | S&A Qualification | -168.67 | 6.12 | Overdue Start | Laura Kennedy |  |  |  |
| 2154 | 1.6.4.1.6.6.14.1 | Test Data Request + Templates Completed |  | 16d | 2025-06-16 | 2025-07-07 |  |  |  | 2025-06-16 | 2025-07-07 | 0d | 32190d | 6d | finish no earlier than 2025-07-07 | Non-SIT S&A QT Test Team | S&A Qualification | 178.33 | 6.12 | Green | Laura Kennedy | GREEN |  |  |
| 2155 | 1.6.4.1.6.6.14.2 | Test Data Generated |  | 10d | 2025-07-16 | 2025-07-29 | 2154 |  |  | 2025-07-16 | 2025-07-29 | 0d | 32184d | 0d | finish no earlier than 2025-07-29 | Non-SIT S&A QT Test Team | S&A Qualification | 208.33 | 6.12 | Green | Laura Kennedy | GREEN |  |  |
| 2156 | 1.6.4.1.6.6.14.3 | Test Data Loaded into QP Systems |  | 16d | 2025-07-30 | 2025-08-20 | 2155 |  |  | 2025-07-30 | 2025-08-20 | 0d | 32184d |  | finish no earlier than 2025-08-12 | Non-SIT S&A QT Test Team | S&A Qualification | 222.33 | 6.12 | Green | Laura Kennedy | GREEN |  |  |
| 2157 | 1.6.4.1.6.6.14.4 | Test Data Loaded into QTF + ADO |  | 16d | 2025-07-30 | 2025-08-20 | 2155 |  |  | 2025-07-30 | 2025-08-20 | 0d | 32184d |  | finish no earlier than 2025-08-12 | Non-SIT S&A QT Test Team | S&A Qualification | 222.33 | 6.12 | Green | Laura Kennedy | GREEN |  |  |
| 2158 | 1.6.4.1.6.6.15 | **Wave 3 Test Data** |  | 45d | 2025-09-08 | 2025-11-10 |  |  |  | 2025-09-08 | 2025-11-10 | 0d |  |  |  | Non-SIT S&A QT Test Team | S&A Qualification | -168.67 | 6.12 | Overdue Start | Laura Kennedy |  |  |  |
| 2159 | 1.6.4.1.6.6.15.1 | Test Data Request + Templates Completed |  | 15d | 2025-08-19 | 2025-09-08 |  |  |  | 2025-08-19 | 2025-09-08 | 0d | 32141d | 5d | finish no earlier than 2025-09-08 | Non-SIT S&A QT Test Team | S&A Qualification | 242.33 | 6.12 | Green | Laura Kennedy | GREEN |  |  |
| 2160 | 1.6.4.1.6.6.15.2 | Test Data Generated |  | 10d | 2025-09-16 | 2025-09-29 | 2159 |  |  | 2025-09-16 | 2025-09-29 | 0d | 32136d | 0d | finish no earlier than 2025-09-29 | Non-SIT S&A QT Test Team | S&A Qualification | 270.33 | 6.12 | Green | Laura Kennedy | GREEN |  |  |
| 2161 | 1.6.4.1.6.6.15.3 | Test Data Loaded into QP Systems |  | 20d | 2025-09-30 | 2025-10-27 | 2160 |  |  | 2025-09-30 | 2025-10-27 | 0d | 32136d |  | finish no earlier than 2025-10-13 | Non-SIT S&A QT Test Team | S&A Qualification | 284.33 | 6.12 | Green | Laura Kennedy | GREEN |  |  |
| 2162 | 1.6.4.1.6.6.15.4 | Test Data Loaded into QTF + ADO |  | 20d | 2025-09-30 | 2025-10-27 | 2160 |  |  | 2025-09-30 | 2025-10-27 | 0d | 32136d |  | finish no earlier than 2025-10-13 | Non-SIT S&A QT Test Team | S&A Qualification | 284.33 | 6.12 | Green | Laura Kennedy | GREEN |  |  |
| 2163 | 1.6.4.1.6.6.16 | **Wave 4 Test Data** |  | 45d | 2025-11-06 | 2026-01-08 |  |  |  | 2025-11-06 | 2026-01-08 | 0d |  |  |  | Non-SIT S&A QT Test Team | S&A Qualification | -168.67 | 6.12 | Overdue Start | Laura Kennedy |  |  |  |
| 2164 | 1.6.4.1.6.6.16.1 | Test Data Request + Templates Completed |  | 15d | 2025-10-17 | 2025-11-06 |  |  |  | 2025-10-17 | 2025-11-06 | 0d | 32098d | 5d | finish no earlier than 2025-11-06 | Non-SIT S&A QT Test Team | S&A Qualification | 301.33 | 6.12 | Green | Laura Kennedy | GREEN |  |  |
| 2165 | 1.6.4.1.6.6.16.2 | Test Data Generated |  | 10d | 2025-11-14 | 2025-11-27 | 2164 |  |  | 2025-11-14 | 2025-11-27 | 0d | 32093d | 0d | finish no earlier than 2025-11-27 | Non-SIT S&A QT Test Team | S&A Qualification | 329.33 | 6.12 | Green | Laura Kennedy | GREEN |  |  |
| 2166 | 1.6.4.1.6.6.16.3 | Test Data Loaded into QP Systems |  | 20d | 2025-11-28 | 2025-12-25 | 2165 |  |  | 2025-11-28 | 2025-12-25 | 0d | 32093d |  | finish no earlier than 2025-12-11 | Non-SIT S&A QT Test Team | S&A Qualification | 343.33 | 6.12 | Green | Laura Kennedy | GREEN |  |  |
| 2167 | 1.6.4.1.6.6.16.4 | Test Data Loaded into QTF + ADO |  | 20d | 2025-11-28 | 2025-12-25 | 2165 |  |  | 2025-11-28 | 2025-12-25 | 0d | 32093d |  | finish no earlier than 2025-12-11 | Non-SIT S&A QT Test Team | S&A Qualification | 343.33 | 6.12 | Green | Laura Kennedy | GREEN |  |  |
| 2168 | 1.6.4.1.6.6.17 | **Governance** |  | 195d | 2024-07-01 A | 2025-03-28 |  | 6% | 182.38d | 2024-07-01 | 2024-12-20 | 0d | 32287d |  |  | Non-SIT S&A QT Test Team | S&A Qualification | -168.67 | 6.12 | Overdue Start | Laura Kennedy | RED |  |  |
| 2169 | 1.6.4.1.6.6.17.1 | Onboarding Strategy and Develop Training Requirements & Materials Inc. Day in the Life |  | 120d | 2024-07-01 | 2024-12-13 | 2037 |  |  | 2024-07-01 | 2024-11-29 | 0d | 32362d | 0d | finish no earlier than 2024-12-13 | Non-SIT S&A QT Test Team | S&A Qualification | -171.67 | 6.12 | Overdue Start | Laura Kennedy | RED |  |  |
| 2170 | 1.6.4.1.6.6.17.2 | Design Approach & Set-Up ADO Tool for Test & Defect Management Tool |  | 20d | 2024-07-01 A | 2024-07-26 A | 2169SS | 100% |  | 2024-07-01 | 2024-07-26 | 0d |  |  |  | Non-SIT S&A QT Test Team | S&A Qualification |  | 6.12 | Complete | Laura Kennedy | COMPLETE |  |  |
| 2171 | 1.6.4.1.6.6.17.3 | Knowledge Transfer, Training, Demonstrations, Documentation, Governance |  | 78d | 2024-08-30 | 2024-12-17 | 2169SS+44d |  |  | 2024-08-30 | 2024-12-17 | 0d | 32360d |  |  | Non-SIT S&A QT Test Team | S&A Qualification | -111.67 | 6.12 | Overdue Start | Laura Kennedy | GREEN |  |  |
| 2172 | 1.6.4.1.6.6.17.4 | BETA Testing |  | 33d | 2024-11-01 | 2024-12-17 |  |  |  | 2024-11-01 | 2024-12-20 | 0d | 32302d | 15d | finish no earlier than 2024-12-17 | Non-SIT S&A QT Test Team | S&A Qualification | -48.67 | 6.12 | Green | Laura Kennedy | GREEN |  |  |
| 2173 | 1.6.4.1.6.6.17.5 | BETA Testing 2 |  | 58d | 2025-01-08 | 2025-03-28 | 2172 |  |  | 2025-01-08 | 2025-03-28 | 0d | 32287d | 0d | start no earlier than 2025-01-08 | Non-SIT S&A QT Test Team | S&A Qualification | 19.33 | 6.13 | Green | Laura Kennedy | GREEN |  |  |
| 2174 | 1.6.4.1.6.6.18 | Qualification Testing Framework Readiness Confirmed | milestone | 0d | 2025-03-28 | 2025-03-28 | 2173 |  |  | 2025-03-28 | 2025-03-28 | 0d | 32287d |  | start no earlier than 2025-03-28 | Non-SIT S&A QT Test Team | S&A Qualification | 98.71 | 6.12 | Green | Laura Kennedy | GREEN |  |  |
| 2175 | 1.6.4.1.6.6.19 | Qualification Testing Wave Readiness Confirmed | milestone | 0d | 2025-08-21 | 2025-08-21 | 2203FS-2d |  |  | 2025-08-21 | 2025-08-21 | 0d | 32184d |  | finish no earlier than 2025-05-30 |  | S&A Qualification | 244.33 | 6.13 | Green |  | GREEN | T2-QU-1100 | T2 |

Notes:
- 2175: 19/12/24 - QAG approved the creation of this milestone. Programme will continue to develop the dependencies feeding into it in due course.

| ID | WBS | Task | Type | Duration | Start | Finish | Predecessors | Complete | Baseline start | Baseline finish | Baseline duration | Total slack | Free slack | Constraint | Baseline cost | Responsible | Involved | Text9 | Task Status | Update Version | MHHS Resource Name | Sched Status | RAG | Milestone ID | Text29 | Tier |
| --- | --- | --- | --- | --- | --- | --- | --- | --- | --- | --- | --- | --- | --- | --- | --- | --- | --- | --- | --- | --- | --- | --- | --- | --- | --- | --- |
| 2176 | 1.6.4.1.7 | **Wave Allocation** |  | 129d | 2024-01-02 A | 2024-06-28 A |  | 100% | 2024-01-02 | 2024-06-28 | 128d |  |  |  | -0 | N/A | N/A | S&A Qualification | -133.67 | 5.24 | N/A |  |  |  |  |  |
| 2177 | 1.6.4.1.7.1 | Draft Pre-Qualification Submission (PQS) document |  | 20d | 2024-01-02 A | 2024-01-29 A |  | 100% | 2024-01-02 | 2024-01-29 | 20d |  |  | finish no earlier than 2024-01-26 |  | Code Bodies | Code Bodies | S&A Qualification |  | 5.24 | Laura Kennedy | Complete | COMPLETE |  |  |  |
| 2178 | 1.6.4.1.7.2 | Publish PQS document |  | 1d | 2024-01-31 A | 2024-01-31 A |  | 100% | 2024-01-31 | 2024-01-31 | 1d |  |  | start no earlier than 2024-01-31 |  | Code Bodies | Code Bodies | S&A Qualification |  | 5.24 | Laura Kennedy | Complete | COMPLETE |  |  |  |
| 2179 | 1.6.4.1.7.3 | PQS Submission window |  | 60d | 2024-02-05 A | 2024-04-26 A |  | 100% | 2024-02-05 | 2024-04-26 | 60d |  |  | start no earlier than 2024-02-05 |  | Participants | Participants | S&A Qualification |  | 5.24 | Laura Kennedy | Complete | COMPLETE |  |  |  |
| 2180 | 1.6.4.1.7.4 | Pre-Qualification Submission and PIT Test Plan Deadline for Submission​ | milestone | 0d | 2024-04-26 A | 2024-04-26 A | 2179 | 100% | 2024-04-26 | 2024-04-26 | 0d |  |  |  |  | Participants | Participants | S&A Qualification |  | 5.25 | Laura Kennedy | Complete | COMPLETE | T3-QU-0118 | QAG | T3 |
| 2181 | 1.6.4.1.7.5 | PQS Review by Code Bodies |  | 25d | 2024-04-29 A | 2024-05-31 A | 2179, 2180 | 100% | 2024-04-29 | 2024-05-31 | 25d |  |  |  |  | Code Bodies | Code Bodies | S&A Qualification |  | 5.24 | Laura Kennedy | Complete | COMPLETE |  |  |  |
| 2182 | 1.6.4.1.7.6 | Draft Wave Allocations |  | 15d | 2024-06-03 A | 2024-06-21 A | 2181 | 100% | 2024-06-03 | 2024-06-21 | 15d |  |  |  |  | Code Bodies | Code Bodies | S&A Qualification |  | 5.24 | Laura Kennedy | Complete | COMPLETE |  |  |  |
| 2183 | 1.6.4.1.7.7 | Confirmation of participant Qualification Wave allocation | milestone | 0d | 2024-06-28 A | 2024-06-28 A | 2182FS+5d | 100% | 2024-06-28 | 2024-06-28 | 0d |  |  |  |  | Code Bodies | Code Bodies | S&A Qualification |  | 5.28 | Laura Kennedy | Complete | COMPLETE | T3-QU-0012 | QAG | T3 |
| 2184 | 1.6.4.2 | **Qualification Wave 1** |  | 248d | 2025-05-05 | 2026-04-15 |  |  | 2025-03-24 | 2026-04-10 | 229d | 31578d |  |  | -0 | N/A | N/A | S&A Qualification | -133.67 | 6.13 | N/A |  |  |  |  |  |
| 2185 | 1.6.4.2.1 | **Qualification Wave 1 QAD Prep** |  | 80d | 2025-05-05 | 2025-08-22 |  |  | 2025-03-24 | 2025-07-11 | 80d | 31579d |  |  | -0 | N/A | N/A | S&A Qualification | -152.67 | 6.13 | N/A |  |  |  |  |  |
| 2186 | 1.6.4.2.1.1 | Initial QAD Submission window opens | milestone | 0d | 2025-05-05 | 2025-05-05 | 2183, 1958FS+11d |  | 2025-05-05 | 2025-05-05 | 0d | 31579d | 0d | start no earlier than 2025-03-24 |  | Participants | Participants | S&A Qualification | 136.71 | 6.13 | Laura Kennedy | Green | GREEN |  |  |  |
| 2187 | 1.6.4.2.1.2 | Qualification Wave 1 Participants Submit Initial QAD |  | 50d | 2025-05-05 | 2025-07-11 | 2186FS-1d |  | 2025-05-05 | 2025-07-11 | 50d | 31579d | 0d |  |  | Participants | Participants | S&A Qualification | 136.33 | 6.13 | Laura Kennedy | Green | GREEN |  |  |  |
| 2188 | 1.6.4.2.1.3 | Qualification Wave 1 Participants have submitted their initial QAD | milestone | 0d | 2025-07-14 | 2025-07-14 | 2187FS+1d |  | 2025-07-14 | 2025-07-14 | 0d | 31579d | 0d |  |  | Participants | Participants | S&A Qualification | 206.71 | 6.13 | Laura Kennedy | Green | GREEN | T3-QU-0094 | QAG | T3 |
| 2189 | 1.6.4.2.1.4 | Code Bodies review of Wave 1 Participants Initial QAD |  | 30d | 2025-07-14 | 2025-08-22 | 2187FS-1d, 2188FS-1d |  | 2025-07-14 | 2025-08-22 | 30d | 31579d | 0d |  |  | Code Bodies | Code Bodies | S&A Qualification | 206.33 | 6.13 | Laura Kennedy | Green | GREEN |  |  |  |
| 2190 | 1.6.4.2.1.5 | Completion of Code Bodies review of Initial QAD | milestone | 0d | 2025-08-22 | 2025-08-22 | 2189 |  | 2025-08-22 | 2025-08-22 | 0d | 31579d | 0d |  |  | Code Bodies | Code Bodies | S&A Qualification | 245.71 | 6.13 | Laura Kennedy | Green | GREEN |  |  |  |
| 2191 | 1.6.4.2.2 | **Qualification Wave 1 Test Prep** |  | 60d | 2025-05-26 | 2025-08-15 |  |  | 2025-04-14 | 2025-07-04 | 60d | 31584d |  |  | -0 | N/A | N/A | S&A Qualification | -555.67 | 6.13 | N/A |  |  |  |  |  |
| 2192 | 1.6.4.2.2.1 | Confirmation from Qualification Wave 1 Participants that DIP onboarding has commenced | milestone | 0d | 2025-05-26 | 2025-05-26 |  |  | 2025-05-26 | 2025-05-26 | 0d | 31604d | 0d | start no earlier than 2025-05-26 |  | Participants | Participants | S&A Qualification | 157.33 | 6.13 | Laura Kennedy | Green | GREEN | T3-QU-0017 | QAG | T3 |
| 2193 | 1.6.4.2.2.2 | Qualification Wave 1 Participants DIP Onboarding Window |  | 35d | 2025-05-26 | 2025-07-11 | 2192 |  | 2025-05-26 | 2025-07-11 | 35d | 31604d | 0d |  |  | Participants | Participants | S&A Qualification | 157.33 | 6.13 | Laura Kennedy | Green | GREEN |  |  |  |
| 2194 | 1.6.4.2.2.3 | Confirmation from Qualification Wave 1 Participants that DIP onboarding has completed | milestone | 0d | 2025-07-11 | 2025-07-11 | 2193 |  | 2025-07-11 | 2025-07-11 | 0d | 31604d | 25d |  |  | Participants | Participants | S&A Qualification | 203.71 | 6.13 | Laura Kennedy | Green | GREEN | T3-TE-0017 | QAG | T3 |
| 2195 | 1.6.4.2.2.4 | Qualification Wave 1 Participants' to provide status of PIT completion and submit QT Test Plan | milestone | 0d | 2025-06-13 | 2025-06-13 |  |  | 2025-06-16 | 2025-06-16 | 0d | 31610d | 0d | start no earlier than 2025-06-13 |  | Participants | Participants | S&A Qualification | 175.33 | 6.13 | Laura Kennedy | Green | GREEN | T3-QU-0095 | QAG | T3 |
| 2196 | 1.6.4.2.2.5 | Review of Participants' PIT Status and QT Test Plan |  | 15d | 2025-06-13 | 2025-07-03 | 2195 |  | 2025-06-16 | 2025-07-04 | 15d | 31610d | 0d |  |  | Code Bodies, Non-SIT S&A QT Test Team | Code Bodies, Non-SIT S&A QT Test Team | S&A Qualification | 175.33 | 6.13 | Laura Kennedy | Green | GREEN |  |  |  |
| 2197 | 1.6.4.2.2.6 | Qualification Test Plans for Wave 1 Participants approved | milestone | 0d | 2025-07-03 | 2025-07-03 | 2196 |  | 2025-07-04 | 2025-07-04 | 0d | 31610d | 31d |  |  | Non-SIT S&A QT Test Team | Non-SIT S&A QT Test Team | S&A Qualification | 195.71 | 6.13 | Laura Kennedy | Green | GREEN | T3-QU-0016 | QAG | T3 |
| 2198 | 1.6.4.2.2.7 | Qualification Wave 1 Participants have submitted PIT Test Completion Report and evidence for QT Entry | milestone | 0d | 2025-07-14 | 2025-07-14 |  |  | 2025-07-14 | 2025-07-14 | 0d | 31579d | 0d | start no earlier than 2025-07-14 |  | Participants | Participants | S&A Qualification | 206.33 | 6.13 | Laura Kennedy | Green | GREEN | T3-QU-0096 | QAG | T3 |
| 2199 | 1.6.4.2.2.8 | Review of Participants PIT Test Completion Report |  | 25d | 2025-07-14 | 2025-08-15 | 2198 |  | 2025-07-14 | 2025-08-15 | 25d | 31579d | 0d |  |  | Code Bodies, Non-SIT S&A QT Test Team | Code Bodies, Non-SIT S&A QT Test Team | S&A Qualification | 206.33 | 6.13 | Laura Kennedy | Green | GREEN |  |  |  |
| 2200 | 1.6.4.2.2.9 | Onboarding to QTF & ADO |  | 25d | 2025-07-14 | 2025-08-15 | 2199SS |  | 2025-07-14 | 2025-08-15 | 25d | 31584d | 6d |  |  | Code Bodies, Non-SIT S&A QT Test Team | Code Bodies, Non-SIT S&A QT Test Team | S&A Qualification | 206.33 | 6.13 | Laura Kennedy | Green | GREEN |  |  |  |

Notes:
- 2194: 26/11/24 - There was duplicative activity in the SIT plan, which we propose to remove. We also propose to move the milestone ID associated with that activity to this task, this is going to QAG for approval.

| ID | WBS | Task | Type | Duration | Start | Finish | Predecessors | Baseline start | Baseline finish | Baseline duration | Total slack | Free slack | Constraint | Baseline cost | Responsible | Involved | Text9 | Task Status | Update Version | MHHS Resource Name | Sched Status | RAG | Milestone ID | Text29 | Tier |
| --- | --- | --- | --- | --- | --- | --- | --- | --- | --- | --- | --- | --- | --- | --- | --- | --- | --- | --- | --- | --- | --- | --- | --- | --- | --- |
| 2201 | 1.6.4.2.3 | **Qualification Wave 1 QT Execution** |  | 105d | 2025-08-18 | 2026-01-09 |  | 2025-08-18 | 2026-01-09 | 100d | 31579d |  |  | -0 | N/A | N/A | S&A Qualification | -152.67 | 6.13 | N/A |  |  |  |  |  |
| 2202 | 1.6.4.2.3.1 | Review Entry Criteria Evidence for each Wave 1 Participant |  | 5d | 2025-08-18 | 2025-08-22 | 2190FF, 2194, 2197, 2199 | 2025-08-18 | 2025-08-22 | 5d | 31579d | 0d |  |  | Non-SIT S&A QT Test Team | Non-SIT S&A QT Test Team | S&A Qualification | 241.33 | 6.13 | Laura Kennedy | Green | GREEN |  |  |  |
| 2203 | 1.6.4.2.3.2 | Qualification Wave 1 Participant Test Readiness Confirmed | milestone | 0d | 2025-08-22 | 2025-08-22 | 2189, 2190, 2202FF | 2025-08-22 | 2025-08-22 | 0d | 31579d | 0d |  |  | Non-SIT S&A QT Test Team | Non-SIT S&A QT Test Team | S&A Qualification | 245.71 | 6.13 | Laura Kennedy | Green | GREEN | T3-QU-0027 | QAG | T3 |
| 2204 | 1.6.4.2.3.3 | Qualification Wave 1 QT Execution Start | milestone | 0d | 2025-08-25 | 2025-08-25 | 2203, 2200, 1557FS+6d | 2025-08-25 | 2025-08-25 | 0d | 31578d | 0d | start no earlier than 2025-07-14 |  | Participants | Participants | S&A Qualification | 248.71 | 6.13 | Laura Kennedy | Green | GREEN | T3-QU-0028 | QAG | T3 |
| 2205 | 1.6.4.2.3.4 | Qualification Wave 1 QT Execution Window |  | 100d | 2025-08-25 | 2026-01-09 | 2204FS-1d | 2025-08-25 | 2026-01-09 | 95d | 31583d | 0d |  |  | Participants | Participants | S&A Qualification | 248.33 | 6.13 | Laura Kennedy | Green | GREEN |  |  |  |
| 2206 | 1.6.4.2.3.5 | Qualification Wave 1 QT Projected Execution End | milestone | 0d | 2026-01-09 | 2026-01-09 | 2205 | 2026-01-09 | 2026-01-09 | 0d | 31583d | 5d |  |  | Participants | Participants | S&A Qualification | 385.71 | 6.13 | Laura Kennedy | Green | GREEN | T3-QU-0054 | QAG | T3 |
| 2207 | 1.6.4.2.4 | **Qualification Wave 1 Exit** |  | 168d | 2025-08-25 | 2026-04-15 |  | 2025-08-25 | 2026-04-15 | 149d? | 31578d |  |  | -0 | N/A | N/A | S&A Qualification | -152.67 | 6.13 | N/A |  |  |  |  |  |
| 2208 | 1.6.4.2.4.1 | Final QAD Submission window opens | milestone | 0d | 2025-08-25 | 2025-08-25 | 2204 | 2025-08-25 | 2025-08-25 | 0d | 31578d | 0d |  |  | Participants | Participants | S&A Qualification | 248.71 | 6.13 | Laura Kennedy | Green | GREEN |  |  |  |
| 2209 | 1.6.4.2.4.2 | Qualification Wave 1 Participants submit their Final QAD |  | 105d | 2025-08-25 | 2026-01-16 | 2208FS-1d | 2025-08-25 | 2026-01-16 | 100d | 31578d | 0d |  |  | Participants | Participants | S&A Qualification | 248.33 | 6.13 | Laura Kennedy | Green | GREEN |  |  |  |
| 2210 | 1.6.4.2.4.3 | Qualification Wave 1 Participants have submitted their final QAD | milestone | 0d | 2026-01-16 | 2026-01-16 | 2209, 2206 | 2026-01-16 | 2026-01-16 | 0d | 31578d | 0d |  |  | Participants | Participants | S&A Qualification | 392.71 | 6.13 | Laura Kennedy | Green | GREEN | T3-QU-0097 | QAG | T3 |
| 2211 | 1.6.4.2.4.4 | Completion of Code Bodies review of Final QAD |  | 35d | 2026-01-19 | 2026-03-06 | 2209, 2210 | 2026-01-19 | 2026-03-06 | 20d | 31578d | 0d |  |  | Code Bodies | Code Bodies | S&A Qualification | 395.33 | 6.13 | Laura Kennedy | Green | GREEN |  |  |  |
| 2212 | 1.6.4.2.4.5 | QAD Sign Off deadline |  | 1d | 2026-03-20 | 2026-03-20 | 2211FS+9d | 2026-03-20 | 2026-03-20 | 1d | 31578d | 0d |  |  | Participants | Participants | S&A Qualification | 455.33 | 6.13 | Laura Kennedy | Green | GREEN |  |  |  |
| 2213 | 1.6.4.2.4.6 | Qualification Wave 1 Participants Qualification approved by BSC PAB and REC Manager | milestone | 0d | 2026-04-15 | 2026-04-15 | 2212FS+18d | 2026-04-15 | 2026-04-15 | 0d | 31578d | 0d |  |  | Code Bodies | Code Bodies | S&A Qualification | 481.71 | 6.13 | Laura Kennedy | Green | GREEN | T2-QU-0150 | QAG | T2 |
| 2214 | 1.6.4.3 | **Qualification Wave 2** |  | 254d | 2025-06-09 | 2026-05-28 |  | 2025-06-09 | 2026-05-28 | 249d | 31578d |  |  | -0 | N/A | N/A | S&A Qualification | -133.67 | 6.13 | N/A |  |  |  |  |  |
| 2215 | 1.6.4.3.1 | **Qualification Wave 2 QAD Prep** |  | 95d | 2025-06-09 | 2025-10-17 |  | 2025-06-09 | 2025-10-17 | 96d | 31578d |  |  | -0 | N/A | N/A | S&A Qualification | -154.67 | 6.13 | N/A |  |  |  |  |  |
| 2216 | 1.6.4.3.1.1 | Initial QAD Submission window opens | milestone | 0d | 2025-06-09 | 2025-06-09 | 1959FS+151d | 2025-06-09 | 2025-06-09 | 0d | 31578d | 0d |  |  | Participants | Participants | S&A Qualification | 171.71 | 6.13 | Laura Kennedy | Green | GREEN |  |  |  |
| 2217 | 1.6.4.3.1.2 | Qualification Wave 2 Participants Submit Initial QAD |  | 70d | 2025-06-09 | 2025-09-12 | 2216FS-1d | 2025-06-09 | 2025-09-12 | 70d | 31578d | 0d |  |  | Participants | Participants | S&A Qualification | 171.33 | 6.13 | Laura Kennedy | Green | GREEN |  |  |  |
| 2218 | 1.6.4.3.1.3 | Qualification Wave 2 Participants have submitted their initial QAD | milestone | 0d | 2025-09-12 | 2025-09-12 | 2217 | 2025-09-12 | 2025-09-12 | 0d | 31578d | 0d |  |  | Participants | Participants | S&A Qualification | 266.71 | 6.13 | Laura Kennedy | Green | GREEN | T3-QU-0098 | QAG | T3 |
| 2219 | 1.6.4.3.1.4 | Code Bodies review of Wave 2 Participants' Initial QAD |  | 25d | 2025-09-15 | 2025-10-17 | 2218 | 2025-09-15 | 2025-10-17 | 26d | 31578d | 0d |  |  | Code Bodies | Code Bodies | S&A Qualification | 269.33 | 6.13 | Laura Kennedy | Green | GREEN |  |  |  |
| 2220 | 1.6.4.3.1.5 | Completion of Code Bodies review of Initial QAD | milestone | 0d | 2025-10-17 | 2025-10-17 | 2219 | 2025-10-17 | 2025-10-17 | 0d | 31578d | 0d |  |  | Code Bodies | Code Bodies | S&A Qualification | 301.71 | 6.13 | Laura Kennedy | Green | GREEN |  |  |  |
| 2221 | 1.6.4.3.2 | **Qualification Wave 2 Test Prep** |  | 60d | 2025-07-21 | 2025-10-10 |  | 2025-07-21 | 2025-10-10 | 60d | 31584d |  |  | -0 | N/A | N/A | S&A Qualification | -555.67 | 6.13 | N/A |  |  |  |  |  |
| 2222 | 1.6.4.3.2.1 | Confirmation from Qualification Wave 2 Participants that DIP Onboarding has commenced | milestone | 0d | 2025-07-21 | 2025-07-21 |  | 2025-07-21 | 2025-07-21 | 0d | 31603d | 0d | start no earlier than 2025-07-21 |  | Participants | Participants | S&A Qualification | 213.33 | 6.13 | Laura Kennedy | Green | GREEN | T3-QU-0021 | QAG | T3 |
| 2223 | 1.6.4.3.2.2 | Qualification Wave 2 Participants DIP Onboarding Window |  | 35d | 2025-07-21 | 2025-09-05 | 2222 | 2025-07-21 | 2025-09-05 | 40d | 31603d | 0d |  |  | Participants | Participants | S&A Qualification | 213.33 | 6.13 | Laura Kennedy | Green | GREEN |  |  |  |
| 2224 | 1.6.4.3.2.3 | Confirmation from Qualificiation Wave 2 Participants that DIP onboarding has completed | milestone | 0d | 2025-09-05 | 2025-09-05 | 2223 | 2025-09-05 | 2025-09-05 | 0d | 31603d | 25d |  |  | Participants | Participants | S&A Qualification | 259.71 | 6.13 | Laura Kennedy | Green | GREEN |  |  |  |
| 2225 | 1.6.4.3.2.4 | Qualification Wave 2 Participants' to provide status of PIT completion and submit QT Test Plan | milestone | 0d | 2025-08-18 | 2025-08-18 |  | 2025-08-18 | 2025-08-18 | 0d | 31603d | 0d | start no earlier than 2025-08-18 |  | Participants | Participants | S&A Qualification | 241.33 | 6.13 | Laura Kennedy | Green | GREEN | T3-QU-0099 | QAG | T3 |
| 2226 | 1.6.4.3.2.5 | Review of Participants' PIT Status and QT Test Plan |  | 15d | 2025-08-18 | 2025-09-05 | 2225 | 2025-08-18 | 2025-09-05 | 15d | 31603d | 0d | start no earlier than 2025-07-07 |  | Code Bodies, Non-SIT S&A QT Test Team | Code Bodies, Non-SIT S&A QT Test Team | S&A Qualification | 241.33 | 6.13 | Laura Kennedy | Green | GREEN |  |  |  |
| 2227 | 1.6.4.3.2.6 | Qualification Test Plans for Wave 2 Participants approved | milestone | 0d | 2025-09-05 | 2025-09-05 | 2226 | 2025-09-05 | 2025-09-05 | 0d | 31603d | 25d | start no earlier than 2025-07-25 |  | Non-SIT S&A QT Test Team | Non-SIT S&A QT Test Team | S&A Qualification | 259.71 | 6.13 | Laura Kennedy | Green | GREEN | T3-QU-0020 | QAG | T3 |
| 2228 | 1.6.4.3.2.7 | Qualification Wave 2 Participants have submitted PIT Test Completion Report and evidence for QT entry | milestone | 0d | 2025-09-08 | 2025-09-08 |  | 2025-09-08 | 2025-09-08 | 0d | 31578d | 0d | start no earlier than 2025-09-08 |  | Participants | Participants | S&A Qualification | 262.33 | 6.13 | Laura Kennedy | Green | GREEN | T3-QU-0100 | QAG | T3 |
| 2229 | 1.6.4.3.2.8 | Review of Participants' PIT Test Completion Report |  | 25d | 2025-09-08 | 2025-10-10 | 2228 | 2025-09-08 | 2025-10-10 | 25d | 31578d | 0d |  |  | Code Bodies, Non-SIT S&A QT Test Team | Code Bodies, Non-SIT S&A QT Test Team | S&A Qualification | 262.33 | 6.13 | Laura Kennedy | Green | GREEN |  |  |  |
| 2230 | 1.6.4.3.2.9 | Onboarding to QTF & ADO |  | 25d | 2025-09-08 | 2025-10-10 | 2229SS | 2025-09-08 | 2025-10-10 | 25d | 31584d | 6d |  |  | Code Bodies, Non-SIT S&A QT Test Team | Code Bodies, Non-SIT S&A QT Test Team | S&A Qualification | 262.33 | 6.13 | Laura Kennedy | Green | GREEN |  |  |  |

| ID | WBS | Task | Type | Duration | Start | Finish | Predecessors | Baseline start | Baseline finish | Baseline duration | Total slack | Free slack | Constraint | Baseline cost | Responsible | Involved | Text9 | Task Status | Update Version | MHHS Resource Name | Sched Status | RAG | Milestone ID | Text29 | Tier |
| --- | --- | --- | --- | --- | --- | --- | --- | --- | --- | --- | --- | --- | --- | --- | --- | --- | --- | --- | --- | --- | --- | --- | --- | --- | --- |
| 2231 | 1.6.4.3.3 | **Qualification Wave 2 QT Execution** |  | 100d | 2025-10-13 | 2026-02-27 |  | 2025-10-13 | 2026-02-27 | 99d | 31578d |  |  | -0 | N/A | N/A | S&A Qualification | -154.67 | 6.13 | N/A |  |  |  |  |  |
| 2232 | 1.6.4.3.3.1 | Review Entry Criteria Evidence for each Wave 2 Participant |  | 5d | 2025-10-13 | 2025-10-17 | 2220FF, 2224, 2227, 2229 | 2025-10-13 | 2025-10-17 | 5d | 31578d | 0d |  |  | Non-SIT S&A QT Test Team | Non-SIT S&A QT Test Team | S&A Qualification | 297.33 | 6.13 | Laura Kennedy | Green | GREEN |  |  |  |
| 2233 | 1.6.4.3.3.2 | Qualification Wave 2 Participant Test Readiness Confirmed | milestone | 0d | 2025-10-17 | 2025-10-17 | 2232, 2220 | 2025-10-17 | 2025-10-17 | 0d | 31578d | 0d |  |  | Non-SIT S&A QT Test Team | Non-SIT S&A QT Test Team | S&A Qualification | 301.71 | 6.13 | Laura Kennedy | Green | GREEN | T3-QU-0033 | QAG | T3 |
| 2234 | 1.6.4.3.3.3 | Qualification Wave 2 Execution Start | milestone | 0d | 2025-10-20 | 2025-10-20 | 2233FS+1d, 2230 | 2025-10-20 | 2025-10-20 | 0d | 31578d | 0d |  |  | Participants | Participants | S&A Qualification | 304.71 | 6.13 | Laura Kennedy | Green | GREEN | T3-QU-0034 | QAG | T3 |
| 2235 | 1.6.4.3.3.4 | Qualification Wave 2 QT Execution Window |  | 95d | 2025-10-20 | 2026-02-27 | 2234SS-1d | 2025-10-20 | 2026-02-27 | 94d | 31583d | 0d |  |  | Participants | Participants | S&A Qualification | 304.33 | 6.13 | Laura Kennedy | Green | GREEN |  |  |  |
| 2236 | 1.6.4.3.3.5 | Qualfication Wave 2 QT Execution End | milestone | 0d | 2026-02-27 | 2026-02-27 | 2235 | 2026-02-27 | 2026-02-27 | 0d | 31583d | 5d |  |  | Participants | Participants | S&A Qualification | 434.71 | 6.13 | Laura Kennedy | Green | GREEN | T3-QU-0055 | QAG | T3 |
| 2237 | 1.6.4.3.4 | **Qualification Wave 2 Exit** |  | 159d | 2025-10-20 | 2026-05-28 |  | 2025-10-20 | 2026-05-28 | 153d | 31578d |  |  | -0 | N/A | N/A | S&A Qualification | -154.67 | 6.13 | N/A |  |  |  |  |  |
| 2238 | 1.6.4.3.4.1 | Final QAD Submission window opens | milestone | 0d | 2025-10-20 | 2025-10-20 | 2234 | 2025-10-20 | 2025-10-20 | 0d | 31578d | 0d |  |  | Participants | Participants | S&A Qualification | 304.71 | 6.13 | Laura Kennedy | Green | GREEN |  |  |  |
| 2239 | 1.6.4.3.4.2 | Qualification Wave 2 Participants submit their Final QAD |  | 100d | 2025-10-20 | 2026-03-06 | 2238FS-1d | 2025-10-20 | 2026-03-06 | 99d | 31578d | 0d |  |  | Participants | Participants | S&A Qualification | 304.33 | 6.13 | Laura Kennedy | Green | GREEN |  |  |  |
| 2240 | 1.6.4.3.4.3 | Qualification Wave 2 Participants have submitted their final QAD | milestone | 0d | 2026-03-06 | 2026-03-06 | 2239, 2236 | 2026-03-06 | 2026-03-06 | 0d | 31578d | 0d |  |  | Participants | Participants | S&A Qualification | 441.71 | 6.13 | Laura Kennedy | Green | GREEN | T3-QU-0101 | QAG | T3 |
| 2241 | 1.6.4.3.4.4 | Completion of Code Bodies review of Final QAD |  | 26d | 2026-03-09 | 2026-04-13 | 2240 | 2026-03-09 | 2026-04-13 | 27d | 31578d | 0d |  |  | Code Bodies | Code Bodies | S&A Qualification | 444.33 | 6.13 | Laura Kennedy | Green | GREEN |  |  |  |
| 2242 | 1.6.4.3.4.5 | QAD Sign Off deadline |  | 1d | 2026-04-20 | 2026-04-20 | 2241FS+4d | 2026-04-20 | 2026-04-20 | 1d | 31578d | 0d |  |  | Participants | Participants | S&A Qualification | 486.33 | 6.13 | Laura Kennedy | Green | GREEN |  |  |  |
| 2243 | 1.6.4.3.4.6 | Qualification Wave 2 Participants Qualification approved by BSC PAB and REC Manager | milestone | 0d | 2026-05-28 | 2026-05-28 | 2242FS+28d | 2026-05-28 | 2026-05-28 | 0d | 31578d | 0d |  |  | Code Bodies | Code Bodies | S&A Qualification | 524.71 | 6.13 | Laura Kennedy | Green | GREEN | T2-QU-0200 | QAG | T2 |
| 2244 | 1.6.4.4 | **Qualification Wave 3** |  | 254d | 2025-08-11 | 2026-07-30 |  | 2025-08-11 | 2026-07-30 | 239d | 60d |  |  | -0 | N/A | N/A | S&A Qualification | -133.67 | 6.13 | N/A |  |  |  |  |  |
| 2245 | 1.6.4.4.1 | **Qualification Wave 3 QAD Prep** |  | 95d | 2025-08-11 | 2025-12-19 |  | 2025-08-11 | 2025-12-19 | 95d | 31582d |  |  | -0 | N/A | N/A | S&A Qualification | -154.67 | 6.13 | N/A |  |  |  |  |  |
| 2246 | 1.6.4.4.1.1 | Initial QAD Submission window opens | milestone | 0d | 2025-08-11 | 2025-08-11 | 1960FS+151d | 2025-08-11 | 2025-08-11 | 0d | 31582d | 0d |  |  | Participants | Participants | S&A Qualification | 234.71 | 6.13 | Laura Kennedy | Green | GREEN |  |  |  |
| 2247 | 1.6.4.4.1.2 | Qualification Wave 3 Participants Submit Initial QAD |  | 65d | 2025-08-11 | 2025-11-07 | 2246FS-1d | 2025-08-11 | 2025-11-07 | 65d | 31582d | 0d |  |  | Participants | Participants | S&A Qualification | 234.33 | 6.13 | Laura Kennedy | Green | GREEN |  |  |  |
| 2248 | 1.6.4.4.1.3 | Qualification Wave 3 Participants have submitted their initial QAD | milestone | 0d | 2025-11-07 | 2025-11-07 | 2247 | 2025-11-07 | 2025-11-07 | 0d | 31582d | 0d |  |  | Participants | Participants | S&A Qualification | 322.71 | 6.13 | Laura Kennedy | Green | GREEN | T3-QU-0102 | QAG | T3 |
| 2249 | 1.6.4.4.1.4 | Code Bodies review of Wave 3 Participants' Initial QAD |  | 30d | 2025-11-10 | 2025-12-19 | 2248 | 2025-11-10 | 2025-12-19 | 30d | 31582d | 0d |  |  | Code Bodies | Code Bodies | S&A Qualification | 325.33 | 6.13 | Laura Kennedy | Green | GREEN |  |  |  |
| 2250 | 1.6.4.4.1.5 | Completion of Code Bodies review of Initial QAD | milestone | 0d | 2025-12-19 | 2025-12-19 | 2249 | 2025-12-19 | 2025-12-19 | 0d | 31582d | 0d |  |  | Code Bodies | Code Bodies | S&A Qualification | 364.71 | 6.13 | Laura Kennedy | Green | GREEN |  |  |  |
| 2251 | 1.6.4.4.2 | **Qualification Wave 3 Test Prep** |  | 65d | 2025-09-15 | 2025-12-12 |  | 2025-09-15 | 2025-12-12 | 65d | 31612d |  |  | -0 | N/A | N/A | S&A Qualification | -555.67 | 6.13 | N/A |  |  |  |  |  |
| 2252 | 1.6.4.4.2.1 | Confirmation from Qualification Wave 3 Participants that DIP Onboarding has commenced | milestone | 0d | 2025-09-15 | 2025-09-15 |  | 2025-09-15 | 2025-09-15 | 0d | 31612d | 0d | start no earlier than 2025-09-15 |  | Participants | Participants | S&A Qualification | 269.33 | 6.13 | Laura Kennedy | Green | GREEN | T3-QU-0025 | QAG | T3 |
| 2253 | 1.6.4.4.2.2 | Qualification Wave 3 Participants DIP Onboarding window |  | 35d | 2025-09-15 | 2025-10-31 | 2252 | 2025-09-15 | 2025-10-31 | 40d | 31612d | 0d | start no earlier than 2025-08-04 |  | Participants | Participants | S&A Qualification | 269.33 | 6.13 | Laura Kennedy | Green | GREEN |  |  |  |
| 2254 | 1.6.4.4.2.3 | Confirmation from Qualification Wave 3 Participants that DIP onboarding has completed | milestone | 0d | 2025-10-31 | 2025-10-31 | 2253 | 2025-10-31 | 2025-10-31 | 0d | 31612d | 30d | start no earlier than 2025-09-22 |  | Participants | Participants | S&A Qualification | 315.71 | 6.13 | Laura Kennedy | Green | GREEN |  |  |  |
| 2255 | 1.6.4.4.2.4 | Qualification Wave 3 Participants' to provide status of PIT completion and submit QT Test Plan | milestone | 0d | 2025-10-20 | 2025-10-20 |  | 2025-10-20 | 2025-10-20 | 0d | 32127d | 0d | start no earlier than 2025-10-20 |  | Participants | Participants | S&A Qualification | 304.33 | 6.13 | Laura Kennedy | Green | GREEN | T3-QU-0103 | QAG | T3 |
| 2256 | 1.6.4.4.2.5 | Review of Participants' PIT Status and QT Test Plan |  | 15d | 2025-10-20 | 2025-11-07 | 2255 | 2025-10-20 | 2025-11-07 | 15d | 32127d | 0d | start no earlier than 2025-09-08 |  | Code Bodies, Non-SIT S&A QT Test Team | Code Bodies, Non-SIT S&A QT Test Team | S&A Qualification | 304.33 | 6.13 | Laura Kennedy | Green | GREEN |  |  |  |
| 2257 | 1.6.4.4.2.6 | Qualification Test Plans for Wave 3 Participants approved | milestone | 0d | 2025-11-07 | 2025-11-07 | 2256 | 2025-11-07 | 2025-11-07 | 0d | 32127d |  | start no earlier than 2025-09-26 |  | Non-SIT S&A QT Test Team | Non-SIT S&A QT Test Team | S&A Qualification | 322.71 | 6.13 | Laura Kennedy | Green | GREEN | T3-QU-0024 | QAG | T3 |
| 2258 | 1.6.4.4.2.7 | Qualification Wave 3 Participants have submitted PIT Test Completion Report and evidence for QT Entry | milestone | 0d | 2025-11-10 | 2025-11-10 |  | 2025-11-10 | 2025-11-10 | 0d | 31582d | 0d | start no earlier than 2025-11-10 |  | Participants | Participants | S&A Qualification | 325.33 | 6.13 | Laura Kennedy | Green | GREEN | T3-QU-0104 | QAG | T3 |
| 2259 | 1.6.4.4.2.8 | Review of Participants' PIT Test Completion Report |  | 25d | 2025-11-10 | 2025-12-12 | 2258 | 2025-11-10 | 2025-12-12 | 30d | 31582d | 0d | start no earlier than 2025-09-29 |  | Code Bodies, Non-SIT S&A QT Test Team | Code Bodies, Non-SIT S&A QT Test Team | S&A Qualification | 325.33 | 6.13 | Laura Kennedy | Green | GREEN |  |  |  |
| 2260 | 1.6.4.4.2.9 | Onboarding to QTF & ADO |  | 25d | 2025-11-10 | 2025-12-12 | 2259SS | 2025-11-10 | 2025-12-12 | 30d | 31582d | 0d | finish no earlier than 2025-10-31 |  |  |  | S&A Qualification | 325.33 | 6.13 | Laura Kennedy | Green | GREEN |  |  |  |

Notes:
- 2243: 14/11/24 - Updated to align with the actual PAB date.

| ID | WBS | Task | Type | Duration | Start | Finish | Predecessors | Baseline start | Baseline finish | Baseline duration | Total slack | Free slack | Constraint | Baseline cost | Responsible | Involved | Text9 | Task Status | Update Version | MHHS Resource Name | Sched Status | RAG | Milestone ID | Text29 | Tier |
| --- | --- | --- | --- | --- | --- | --- | --- | --- | --- | --- | --- | --- | --- | --- | --- | --- | --- | --- | --- | --- | --- | --- | --- | --- | --- |
| 2261 | 1.6.4.4.3 | **Qualification Wave 3 QT Execution** |  | 102d | 2025-11-03 | 2026-03-24 |  | 2025-11-03 | 2026-03-24 | 100d |  |  |  | -0 | N/A | N/A | S&A Qualification | -154.67 | 6.13 | N/A |  |  |  |  |  |
| 2262 | 1.6.4.4.3.1 | Review Entry Criteria Evidence for each Wave 3 Participant |  | 5d | 2025-12-15 | 2025-12-19 | 2254, 2250FF, 2260 | 2025-12-15 | 2025-12-19 | 5d | 31582d | 0d | start no earlier than 2025-11-03 |  | Non-SIT S&A QT Test Team | Non-SIT S&A QT Test Team | S&A Qualification | 360.33 | 6.13 | Laura Kennedy | Green | GREEN |  |  |  |
| 2263 | 1.6.4.4.3.2 | Qualification Wave 3 Participant Test Readiness confirmed | milestone | 0d | 2025-12-19 | 2025-12-19 | 2254, 2262 | 2025-12-19 | 2025-12-19 | 0d | 31582d | 0d |  |  | Non-SIT S&A QT Test Team | Non-SIT S&A QT Test Team | S&A Qualification | 364.71 | 6.13 | Laura Kennedy | Green | GREEN | T3-QU-0038 | QAG | T3 |
| 2264 | 1.6.4.4.3.3 | Qualification Wave 3 Execution Start | milestone | 0d | 2026-01-12 | 2026-01-12 | 2263FS+16d, 2260FS+1d | 2026-01-12 | 2026-01-12 | 0d | 31582d | 0d | start no earlier than 2025-11-03 |  | Participants | Participants | S&A Qualification | 388.71 | 6.13 | Laura Kennedy | Green | GREEN | T3-QU-0039 | QAG | T3 |
| 2265 | 1.6.4.4.3.4 | Qualification Wave 3 QT Execution Window |  | 90d | 2026-01-12 | 2026-05-15 | 2262, 2264FS-1d | 2026-01-12 | 2026-05-15 | 95d | 31587d | 0d |  |  | Participants | Participants | S&A Qualification | 388.33 | 6.13 | Laura Kennedy | Green | GREEN |  |  |  |
| 2266 | 1.6.4.4.3.5 | Qualification Wave 3 Projected Execution End | milestone | 0d | 2026-05-15 | 2026-05-15 | 2265 | 2026-05-15 | 2026-05-15 | 0d | 31587d | 5d |  |  | Participants | Participants | S&A Qualification | 511.71 | 6.13 | Laura Kennedy | Green | GREEN | T3-QU-0056 | QAG | T3 |
| 2267 | 1.6.4.4.4 | **Qualification Wave 3 Exit** |  | 144d | 2026-01-12 | 2026-07-30 |  | 2026-01-12 | 2026-07-30 | 144d | 31582d |  |  | -0 | N/A | N/A | S&A Qualification | -154.67 | 6.13 | N/A |  |  |  |  |  |
| 2268 | 1.6.4.4.4.1 | Final QAD Submission window opens | milestone | 0d | 2026-01-12 | 2026-01-12 | 2264 | 2026-01-12 | 2026-01-12 | 0d | 31582d | 0d |  |  | Participants | Participants | S&A Qualification | 388.71 | 6.13 | Laura Kennedy | Green | GREEN |  |  |  |
| 2269 | 1.6.4.4.4.2 | Qualification Wave 3 Participants submit their Final QAD |  | 95d | 2026-01-12 | 2026-05-22 | 2268FS-1d | 2026-01-12 | 2026-05-22 | 100d | 31582d | 0d |  |  | Participants | Participants | S&A Qualification | 388.33 | 6.13 | Laura Kennedy | Green | GREEN |  |  |  |
| 2270 | 1.6.4.4.4.3 | Qualification Wave 3 Participants have submitted their Final QAD | milestone | 0d | 2026-05-22 | 2026-05-22 | 2269, 2266 | 2026-05-22 | 2026-05-22 | 0d | 31582d | 0d |  |  | Participants | Participants | S&A Qualification | 518.71 | 6.13 | Laura Kennedy | Green | GREEN | T3-QU-0105 | QAG | T3 |
| 2271 | 1.6.4.4.4.4 | Completion of Code Bodies review of Final QAD |  | 20d | 2026-05-25 | 2026-06-19 | 2270 | 2026-05-25 | 2026-06-19 | 20d | 31582d | 0d |  |  | Code Bodies | Code Bodies | S&A Qualification | 521.33 | 6.13 | Laura Kennedy | Green | GREEN |  |  |  |
| 2272 | 1.6.4.4.4.5 | QAD Sign Off deadline |  | 1d | 2026-06-26 | 2026-06-26 | 2271FS+4d | 2026-06-26 | 2026-06-26 | 1d | 31582d | 0d |  |  | Participants | Participants | S&A Qualification | 553.33 | 6.13 | Laura Kennedy | Green | GREEN |  |  |  |
| 2273 | 1.6.4.4.4.6 | Qualification Wave 3 Participants Qualification approved by BSC PAB and REC Manager | milestone | 0d | 2026-07-30 | 2026-07-30 | 2272FS+24d | 2026-07-30 | 2026-07-30 | 0d | 31582d | 0d |  |  | Code Bodies | Code Bodies | S&A Qualification | 587.71 | 6.13 | Laura Kennedy | Green | GREEN | T2-QU-0250 | QAG | T2 |
| 2274 | 1.6.4.5 | **Qualification Wave 4** |  | 334d | 2025-10-20 | 2027-01-28 |  | 2025-10-20 | 2027-01-28 | 249d | 31573d |  |  | -0 | N/A | N/A | S&A Qualification | -133.67 | 6.13 | N/A |  |  |  |  |  |
| 2275 | 1.6.4.5.1 | **Qualification Wave 4 QAD Prep** |  | 95d | 2025-10-20 | 2026-02-27 |  | 2025-10-20 | 2026-02-27 | 99d | 31573d |  |  | -0 | N/A | N/A | S&A Qualification | -155.67 | 6.13 | N/A |  |  |  |  |  |
| 2276 | 1.6.4.5.1.1 | Initial QAD Submission window opens | milestone | 0d | 2025-10-20 | 2025-10-20 | 1961FS+161d | 2025-10-20 | 2025-10-20 | 0d | 31573d | 0d |  |  | Participants | Participants | S&A Qualification | 304.71 | 6.13 | Laura Kennedy | Green | GREEN |  |  |  |
| 2277 | 1.6.4.5.1.2 | Qualification Wave 4 Participants Submit Initial QAD |  | 65d | 2025-10-20 | 2026-01-16 | 2276FS-1d | 2025-10-20 | 2026-01-16 | 70d | 31573d | 0d |  |  | Participants | Participants | S&A Qualification | 304.33 | 6.13 | Laura Kennedy | Green | GREEN |  |  |  |
| 2278 | 1.6.4.5.1.3 | Qualification Wave 4 Participants have submitted their Initial QAD | milestone | 0d | 2026-01-16 | 2026-01-16 | 2277 | 2026-01-16 | 2026-01-16 | 0d | 31573d | 0d |  |  | Participants | Participants | S&A Qualification | 392.71 | 6.13 | Laura Kennedy | Green | GREEN | T3-QU-0106 | QAG | T3 |
| 2279 | 1.6.4.5.1.4 | Code Bodies review of Wave 4 Participants' Initial QAD |  | 30d | 2026-01-19 | 2026-02-27 | 2278 | 2026-01-19 | 2026-02-27 | 29d | 31573d | 0d |  |  | Code Bodies | Code Bodies | S&A Qualification | 395.33 | 6.13 | Laura Kennedy | Green | GREEN |  |  |  |
| 2280 | 1.6.4.5.1.5 | Completion of Code Bodies review of Initial QAD | milestone | 0d | 2026-02-27 | 2026-02-27 | 2279 | 2026-02-27 | 2026-02-27 | 0d | 31573d | 0d |  |  | Code Bodies | Code Bodies | S&A Qualification | 434.71 | 6.13 | Laura Kennedy | Green | GREEN |  |  |  |
| 2281 | 1.6.4.5.2 | **Qualification Wave 4 Test Prep** |  | 75d | 2025-11-03 | 2026-02-13 |  | 2025-11-03 | 2026-02-13 | 67d | 31589d |  |  | -0 | N/A | N/A | S&A Qualification | -555.67 | 6.13 | N/A |  |  |  |  |  |
| 2282 | 1.6.4.5.2.1 | Confirmation from Qualification 4 Participants that DIP Onboarding has commenced | milestone | 0d | 2025-11-03 | 2025-11-03 |  | 2025-11-03 | 2025-11-03 | 0d | 31623d | 0d | start no earlier than 2025-11-03 |  | Participants | Participants | S&A Qualification | 318.33 | 6.13 | Laura Kennedy | Green | GREEN | T3-QU-0031 | QAG | T3 |
| 2283 | 1.6.4.5.2.2 | Qualification Wave 4 Participants DIP Onboarding Window |  | 35d | 2025-11-03 | 2025-12-19 | 2282 | 2025-11-03 | 2025-12-19 | 42d | 31623d | 0d |  |  | Participants | Participants | S&A Qualification | 318.33 | 6.13 | Laura Kennedy | Green | GREEN |  |  |  |
| 2284 | 1.6.4.5.2.3 | Confirmation from Qualification Wave 4 Participants that DIP onboarding has completed | milestone | 0d | 2025-12-19 | 2025-12-19 | 2283 | 2025-12-19 | 2025-12-19 | 0d | 31623d | 50d |  |  | Participants | Participants | S&A Qualification | 364.71 | 6.13 | Laura Kennedy | Green | GREEN |  |  |  |
| 2285 | 1.6.4.5.2.4 | Qualification Wave 4 Participants' to provide status of PIT completion and submit QT Test Plan | milestone | 0d | 2025-12-08 | 2025-12-08 |  | 2025-12-08 | 2025-12-08 | 0d | 31589d | 0d | start no earlier than 2025-12-08 |  | Participants | Participants | S&A Qualification | 353.33 | 6.13 | Laura Kennedy | Green | GREEN | T3-QU-0107 | QAG | T3 |
| 2286 | 1.6.4.5.2.5 | Review of Participants' PIT Status and QT Test Plan |  | 25d | 2025-12-08 | 2026-01-09 | 2285 | 2025-12-08 | 2026-01-09 | 16d | 31589d | 0d |  |  | Code Bodies, Non-SIT S&A QT Test Team | Code Bodies, Non-SIT S&A QT Test Team | S&A Qualification | 353.33 | 6.13 | Laura Kennedy | Green | GREEN |  |  |  |
| 2287 | 1.6.4.5.2.6 | Qualification Test Plans for Qualification Wave 4 Participants approved | milestone | 0d | 2026-01-09 | 2026-01-09 | 2286 | 2026-01-09 | 2026-01-09 | 0d | 31589d | 0d |  |  | Non-SIT S&A QT Test Team | Non-SIT S&A QT Test Team | S&A Qualification | 385.71 | 6.13 | Laura Kennedy | Green | GREEN | T3-QU-0030 | QAG | T3 |
| 2288 | 1.6.4.5.2.7 | Qualification Wave 4 Participants have submitted PIT Test Completion Report and evidence for QT entry | milestone | 0d | 2026-01-09 | 2026-01-09 | 2287 | 2026-01-09 | 2026-01-09 | 0d | 31589d | 0d |  |  | Participants | Participants | S&A Qualification | 385.71 | 6.13 | Laura Kennedy | Green | GREEN | T3-QU-0108 | QAG | T3 |
| 2289 | 1.6.4.5.2.8 | Review of Participants' PIT Test Completion Report |  | 25d | 2026-01-12 | 2026-02-13 | 2288 | 2026-01-12 | 2026-02-13 | 30d | 31589d | 0d |  |  | Code Bodies, Non-SIT S&A QT Test Team | Code Bodies, Non-SIT S&A QT Test Team | S&A Qualification | 388.33 | 6.13 | Laura Kennedy | Green | GREEN |  |  |  |
| 2290 | 1.6.4.5.2.9 | Onboarding to QTF & ADO |  | 25d | 2026-01-12 | 2026-02-13 | 2289SS | 2026-01-12 | 2026-02-13 | 30d | 31589d | 16d | start no earlier than 2025-11-24 |  | Code Bodies, Non-SIT S&A QT Test Team | Code Bodies, Non-SIT S&A QT Test Team | S&A Qualification | 388.33 | 6.13 | Laura Kennedy | Green | GREEN |  |  |  |

| ID | WBS | Task | Type | Duration | Start | Finish | Predecessors | Complete | Remaining | Baseline start | Baseline finish | Baseline duration | Baseline 1 start | Baseline 1 finish | Total slack | Free slack | Constraint | Baseline cost | Responsible | Involved | Text9 | Task Status | Update Version | MHHS Resource Name | Sched Status | RAG | Milestone ID | Text29 | Tier | MHHS Programme Phase | Artefact ID |
| --- | --- | --- | --- | --- | --- | --- | --- | --- | --- | --- | --- | --- | --- | --- | --- | --- | --- | --- | --- | --- | --- | --- | --- | --- | --- | --- | --- | --- | --- | --- | --- |
| 2291 | 1.6.4.5.3 | **Qualification Wave 4 QT Execution** |  | 100d | 2026-03-02 | 2026-07-17 |  |  |  | 2026-03-02 | 2026-07-17 | 101d |  |  | 31573d |  |  | -0 | N/A | N/A | S&A Qualification | -155.67 | 6.13 | N/A |  |  |  |  |  |  |  |
| 2292 | 1.6.4.5.3.1 | Review Entry Criteria Evidence for each Wave 4 Participant |  | 5d | 2026-03-02 | 2026-03-06 | 2280FF+5d, 2284 |  |  | 2026-03-02 | 2026-03-06 | 5d |  |  | 31573d | 0d |  |  | Non-SIT S&A QT Test Team | Non-SIT S&A QT Test Team | S&A Qualification | 437.33 | 6.13 | Laura Kennedy | Green | GREEN |  |  |  |  |  |
| 2293 | 1.6.4.5.3.2 | Qualification Wave 4 Participant Test Readiness Confirmed | milestone | 0d | 2026-03-06 | 2026-03-06 | 2284, 2292 |  |  | 2026-03-06 | 2026-03-06 | 0d |  |  | 31573d | 0d |  |  | Non-SIT S&A QT Test Team | Non-SIT S&A QT Test Team | S&A Qualification | 441.71 | 6.13 | Laura Kennedy | Green | GREEN | T3-QU-0043 | QAG | T3 |  |  |
| 2294 | 1.6.4.5.3.3 | Qualification Wave 4 QT Execution Start | milestone | 0d | 2026-03-09 | 2026-03-09 | 2293FS+1d, 2290 |  |  | 2026-03-09 | 2026-03-09 | 0d |  |  | 31573d | 0d | start no earlier than 2026-01-07 |  | Participants | Participants | S&A Qualification | 444.71 | 6.13 | Laura Kennedy | Green | GREEN | T3-QU-0044 | QAG | T3 |  |  |
| 2295 | 1.6.4.5.3.4 | Qualification Wave 4 QT Execution Window |  | 95d | 2026-03-09 | 2026-07-17 | 2294FS-1d, 2292 |  |  | 2026-03-09 | 2026-07-17 | 96d |  |  | 31578d | 0d |  |  | Participants | Participants | S&A Qualification | 444.33 | 6.13 | Laura Kennedy | Green | GREEN |  |  |  |  |  |
| 2296 | 1.6.4.5.3.5 | Qualification Wave 4 Projected Execution End | milestone | 0d | 2026-07-17 | 2026-07-17 | 2295 |  |  | 2026-07-17 | 2026-07-17 | 0d |  |  | 31578d | 5d |  |  | Participants | Participants | S&A Qualification | 574.71 | 6.13 | Laura Kennedy | Green | GREEN | T3-QU-0057 | QAG | T3 |  |  |
| 2297 | 1.6.4.5.4 | **Qualification Wave 4 Exit** |  | 144d | 2026-03-09 | 2026-09-24 |  |  |  | 2026-03-09 | 2026-09-24 | 150d |  |  | 31573d |  |  | -0 | N/A | N/A | S&A Qualification | -155.67 | 6.13 | N/A |  |  |  |  |  |  |  |
| 2298 | 1.6.4.5.4.1 | Final QAD Submission window opens | milestone | 0d | 2026-03-09 | 2026-03-09 | 2294 |  |  | 2026-03-09 | 2026-03-09 | 0d |  |  | 31573d | 0d |  |  | Participants | Participants | S&A Qualification | 444.71 | 6.13 | Laura Kennedy | Green | GREEN |  |  |  |  |  |
| 2299 | 1.6.4.5.4.2 | Qualification Wave 4 Participants submit their Final QAD |  | 100d | 2026-03-09 | 2026-07-24 | 2298FS-1d |  |  | 2026-03-09 | 2026-07-24 | 101d |  |  | 31573d | 0d |  |  | Participants | Participants | S&A Qualification | 444.33 | 6.13 | Laura Kennedy | Green | GREEN |  |  |  |  |  |
| 2300 | 1.6.4.5.4.3 | Qualification Wave 4 Participants have submitted their Final QAD | milestone | 0d | 2026-07-24 | 2026-07-24 | 2299, 2296 |  |  | 2026-07-24 | 2026-07-24 | 0d |  |  | 31573d | 0d |  |  | Participants | Participants | S&A Qualification | 581.71 | 6.13 | Laura Kennedy | Green | GREEN | T3-QU-0109 | QAG | T3 |  |  |
| 2301 | 1.6.4.5.4.4 | Completion of Code Bodies review of Final QAD |  | 20d | 2026-07-27 | 2026-08-21 | 2300 |  |  | 2026-07-27 | 2026-08-21 | 25d |  |  | 31573d | 0d |  |  | Code Bodies | Code Bodies | S&A Qualification | 584.33 | 6.13 | Laura Kennedy | Green | GREEN |  |  |  |  |  |
| 2302 | 1.6.4.5.4.5 | QAD Sign Off deadline |  | 1d | 2026-08-28 | 2026-08-28 | 2301FS+4d |  |  | 2026-08-28 | 2026-08-28 | 1d |  |  | 31573d | 0d |  |  | Participants | Participants | S&A Qualification | 616.33 | 6.13 | Laura Kennedy | Green | GREEN |  |  |  |  |  |
| 2303 | 1.6.4.5.4.6 | Qualification Wave 4 Participants Qualification approved by BSC PAB and REC Manager | milestone | 0d | 2026-09-24 | 2026-09-24 | 2302FS+19d |  |  | 2026-09-24 | 2026-09-24 | 0d |  |  | 31573d | 0d |  |  | Code Bodies | Code Bodies | S&A Qualification | 643.71 | 6.13 | Laura Kennedy | Green | GREEN | T2-QU-0300 | QAG | T3 |  |  |
| 2304 | 1.6.4.5.5 | **Qualification Tier 1 Milestone** |  | 66d | 2026-10-28 | 2027-01-28 |  |  |  | 2026-10-28 | 2027-01-28 | 0d |  |  | 31808d |  |  |  |  |  | S&A Qualification | -686.67 | 6.13 |  | Overdue Start |  |  |  |  |  |  |
| 2305 | 1.6.4.5.5.1 | All suppliers must be able to access MPANs under the new TOM (M14) | milestone | 0d | 2026-10-28 | 2026-10-28 | 2303FS+24d |  |  | 2026-10-28 | 2026-10-28 | 0d | 2026-03-16 | 2026-03-16 | 31808d | 0d | start no earlier than 2026-03-12 |  | CPT | CPT | S&A Qualification | 677.71 | 6.13 | CPT | Green | GREEN | T1-MI-5000 | PSG | T1 | Migration |  |
| 2306 | 1.6.4.5.5.2 | All suppliers must be able to access MPANs under the new TOM (M14*) - Late Exit | milestone | 0d | 2027-01-28 | 2027-01-28 | 2305FS+66d |  |  | 2027-01-28 | 2027-01-28 | 0d | 2026-06-16 | 2026-06-16 | 31808d |  |  |  | CPT | CPT | S&A Qualification | 769.71 | 6.13 | CPT | Green | GREEN | T1-MI-5500 | PSG | T1 | Migration |  |
| 2307 | 1.7 | **REGULATORY** |  | 823d | 2022-10-31 A | 2025-12-24 |  | 99% | 4.98d | 2022-10-31 | 2025-12-24 | 680d | 2022-10-31 | 2025-03-07 | 32094d |  |  | -0 | N/A | N/A | Regulatory |  |  | N/A |  |  |  |  |  | Regulatory |  |
| 2308 | 1.7.1 | **Baseline MHHS Code Changes** |  | 475d | 2022-10-31 A | 2024-08-23 A |  | 100% |  | 2022-10-31 | 2024-08-23 | 475d | 2022-10-31 | 2024-08-23 |  |  |  | -0 | N/A | N/A | Regulatory |  | 5.0 | N/A |  |  |  |  |  | Regulatory |  |
| 2309 | 1.7.1.1 | **Preparation and planning** |  | 35d | 2022-10-31 A | 2022-12-16 A |  | 100% |  | 2022-10-31 | 2022-12-16 | 35d | 2022-10-31 | 2022-12-16 |  |  |  |  | N/A | N/A | Regulatory |  | 5.0 | N/A |  |  |  |  |  | Regulatory |  |
| 2310 | 1.7.1.1.1 | Impact assessment of Programme design on codes to determine required changes |  | 20d | 2022-10-31 A | 2022-11-25 A | 47 | 100% |  | 2022-10-31 | 2022-11-25 | 20d | 2022-10-31 | 2022-11-25 |  |  |  |  | Code Bodies,SRO Code Drafters | Code Drafting PM | Regulatory |  | 5.0 | Andrew Margan | Complete | COMPLETE |  |  |  | Regulatory |  |
| 2311 | 1.7.1.1.2 | Become 'code draft ready' |  | 35d | 2022-10-31 A | 2022-12-16 A |  | 100% |  | 2022-10-31 | 2022-12-16 | 35d | 2022-10-31 | 2022-12-16 |  |  |  |  | Code Bodies,SRO Code Drafters | Code Drafting PM | Regulatory |  | 5.0 | Andrew Margan | Complete | COMPLETE |  |  |  | Regulatory |  |
| 2312 | 1.7.1.1.3 | Soft start drafting where possible |  | 35d | 2022-10-31 A | 2022-12-16 A |  | 100% |  | 2022-10-31 | 2022-12-16 | 35d | 2022-10-31 | 2022-12-16 |  |  |  |  | Code Bodies,SRO Code Drafters | Code Drafting PM | Regulatory |  | 5.0 | Andrew Margan | Complete | COMPLETE |  |  |  | Regulatory |  |
| 2313 | 1.7.1.2 | **Code drafting** |  | 443d | 2022-12-12 A | 2024-08-21 A |  | 100% |  | 2022-12-12 | 2024-08-21 | 445d | 2022-12-12 | 2024-08-23 |  |  |  | -0 | N/A | N/A | Regulatory | M6 | 5.0 | N/A |  |  |  |  |  | Regulatory |  |
| 2314 | 1.7.1.2.1 | **Data Services (BSC driven)** |  | 118d | 2022-12-12 A | 2023-05-24 A |  | 100% |  | 2022-12-12 | 2023-05-24 | 118d | 2022-12-12 | 2023-05-24 |  |  |  |  | N/A | N/A | Regulatory | M6 | 5.0 | N/A |  |  |  |  |  | Regulatory |  |
| 2315 | 1.7.1.2.1.1 | Pre Code Drafting activities |  | 5d | 2022-12-12 A | 2022-12-16 A |  | 100% |  | 2022-12-12 | 2022-12-16 | 5d | 2022-12-12 | 2022-12-16 |  |  | start no earlier than 2022-12-12 |  | Code Drafting PM |  | Regulatory |  | 5.0 | Andrew Margan | Complete | COMPLETE |  |  |  | Regulatory |  |
| 2316 | 1.7.1.2.1.2 | Code and subsidiary document drafting takes place offline |  | 19d | 2023-01-03 A | 2023-01-27 A | 2315FS+11d | 100% |  | 2023-01-03 | 2023-01-27 | 19d | 2023-01-03 | 2023-01-27 |  |  |  |  | Code Bodies,SRO Design | Code Drafting PM | Regulatory |  | 5.0 | Andrew Margan | Complete | COMPLETE |  |  |  | Regulatory |  |
| 2317 | 1.7.1.2.1.3 | Internal review and cross-checking of drafting across code drafters |  | 11d | 2023-01-30 A | 2023-02-13 A | 2316 | 100% |  | 2023-01-30 | 2023-02-13 | 11d | 2023-01-30 | 2023-02-13 |  |  |  |  | Code Bodies,SRO Design | Code Drafting PM | Regulatory |  | 5.0 | Andrew Margan | Complete | COMPLETE |  |  |  | Regulatory |  |
| 2318 | 1.7.1.2.1.4 | External industry review via consultation |  | 20d | 2023-02-14 A | 2023-03-13 A | 2317 | 100% |  | 2023-02-14 | 2023-03-13 | 20d | 2023-02-14 | 2023-03-13 |  |  |  |  | PP | Code Drafting PM | Regulatory |  | 5.0 | Andrew Margan | Complete | COMPLETE |  |  |  | Regulatory |  |
| 2319 | 1.7.1.2.1.5 | Triage and action comments |  | 19d | 2023-03-10 A | 2023-04-05 A | 2318FS-2d | 100% |  | 2023-03-10 | 2023-04-05 | 19d | 2023-03-10 | 2023-04-05 |  |  |  |  | Code Bodies,SRO Design | Code Drafting PM | Regulatory |  | 5.0 | Andrew Margan | Complete | COMPLETE |  |  |  | Regulatory |  |
| 2320 | 1.7.1.2.1.6 | CDWG review |  | 30d | 2023-04-06 A | 2023-05-17 A | 2319 | 100% |  | 2023-04-06 | 2023-05-17 | 30d | 2023-04-06 | 2023-05-17 |  |  |  |  | PP | Code Drafting PM | Regulatory |  | 5.0 | Andrew Margan | Complete | COMPLETE |  |  |  | Regulatory |  |
| 2321 | 1.7.1.2.1.7 | CCAG review |  | 5d | 2023-05-18 A | 2023-05-24 A | 2320 | 100% |  | 2023-05-18 | 2023-05-24 | 5d | 2023-05-18 | 2023-05-24 |  |  |  |  | PP |  | Regulatory |  | 5.0 | Andrew Margan | Complete | COMPLETE |  |  |  | Regulatory |  |
| 2322 | 1.7.1.2.1.8 | Code drafting for Data Services topic area approved | milestone | 0d | 2023-05-24 A | 2023-05-24 A | 2321 | 100% |  | 2023-05-24 | 2023-05-24 | 0d | 2023-05-24 | 2023-05-24 |  |  |  |  | PP | Code Drafting PM | Regulatory |  | 5.0 | Andrew Margan | Complete | COMPLETE | T2-RE-0100 | CCAG | T2 | Regulatory | MHHS-ART060 |

Notes:
- 2305: Future RAG: All suppliers must be able to accept MPANs under the new TOM (one way gate)
- 2306: Future RAG: All suppliers must be able to accept MPANs under the new TOM (one way gate)

| ID | WBS | Task | Type | Duration | Start | Finish | Predecessors | Complete | Baseline start | Baseline finish | Baseline duration | Baseline 1 start | Baseline 1 finish | Constraint | Responsible | Involved | Text9 | Task Status | Update Version | MHHS Resource Name | MHHS Programme Phase | Sched Status | RAG | Artefact ID | Milestone ID | Text29 | Tier |
| --- | --- | --- | --- | --- | --- | --- | --- | --- | --- | --- | --- | --- | --- | --- | --- | --- | --- | --- | --- | --- | --- | --- | --- | --- | --- | --- | --- |
| 2323 | 1.7.1.2.2 | **Metering (REC driven)** |  | 118d | 2022-12-12 A | 2023-05-24 A |  | 100% | 2022-12-12 | 2023-05-24 | 118d | 2022-12-12 | 2023-05-24 |  | N/A | N/A | Regulatory | M6 | 5.0 | N/A | Regulatory |  |  |  |  |  |  |
| 2324 | 1.7.1.2.2.1 | Pre Code Drafting activities |  | 5d | 2022-12-12 A | 2022-12-16 A | 2315SS | 100% | 2022-12-12 | 2022-12-16 | 5d | 2022-12-12 | 2022-12-16 |  | Code Drafting PM |  | Regulatory |  | 5.0 | Andrew Margan | Regulatory | Complete | COMPLETE |  |  |  |  |
| 2325 | 1.7.1.2.2.2 | Code and subsidiary document drafting takes place offline |  | 19d | 2023-01-03 A | 2023-01-27 A | 2324FS+11d | 100% | 2023-01-03 | 2023-01-27 | 19d | 2023-01-03 | 2023-01-27 |  | Code Bodies,SRO Design | Code Drafting PM | Regulatory |  | 5.0 | Andrew Margan | Regulatory | Complete | COMPLETE |  |  |  |  |
| 2326 | 1.7.1.2.2.3 | Internal review and cross-checking of drafting across code drafters |  | 11d | 2023-01-30 A | 2023-02-13 A | 2325 | 100% | 2023-01-30 | 2023-02-13 | 11d | 2023-01-30 | 2023-02-13 |  | Code Bodies,SRO Design | Code Drafting PM | Regulatory |  | 5.0 | Andrew Margan | Regulatory | Complete | COMPLETE |  |  |  |  |
| 2327 | 1.7.1.2.2.4 | External industry review via consultation |  | 20d | 2023-02-14 A | 2023-03-13 A | 2326 | 100% | 2023-02-14 | 2023-03-13 | 20d | 2023-02-14 | 2023-03-13 |  | PP | Code Drafting PM | Regulatory |  | 5.0 | Andrew Margan | Regulatory | Complete | COMPLETE |  |  |  |  |
| 2328 | 1.7.1.2.2.5 | Triage and action comments |  | 19d | 2023-03-10 A | 2023-04-05 A | 2327FS-2d | 100% | 2023-03-10 | 2023-04-05 | 19d | 2023-03-10 | 2023-04-05 |  | Code Bodies,SRO Design | Code Drafting PM | Regulatory |  | 5.0 | Andrew Margan | Regulatory | Complete | COMPLETE |  |  |  |  |
| 2329 | 1.7.1.2.2.6 | CDWG review |  | 30d | 2023-04-06 A | 2023-05-17 A | 2328 | 100% | 2023-04-06 | 2023-05-17 | 30d | 2023-04-06 | 2023-05-17 |  | PP | Code Drafting PM | Regulatory |  | 5.0 | Andrew Margan | Regulatory | Complete | COMPLETE |  |  |  |  |
| 2330 | 1.7.1.2.2.7 | CCAG review |  | 5d | 2023-05-18 A | 2023-05-24 A | 2329 | 100% | 2023-05-18 | 2023-05-24 | 5d | 2023-05-18 | 2023-05-24 |  | PP |  | Regulatory |  | 5.0 | Andrew Margan | Regulatory | Complete | COMPLETE |  |  |  |  |
| 2331 | 1.7.1.2.2.8 | Code drafting for Metering topic area approved | milestone | 0d | 2023-05-24 A | 2023-05-24 A | 2330 | 100% | 2023-05-24 | 2023-05-24 | 0d | 2023-05-24 | 2023-05-24 |  | PP | Code Drafting PM | Regulatory |  | 5.0 | Andrew Margan | Regulatory | Complete | COMPLETE | MHHS-ART060 | T2-RE-0150 | CCAG | T2 |
| 2332 | 1.7.1.2.3 | **BSC Central Services (BSC driven)** |  | 156d | 2023-02-22 A | 2023-09-27 A |  | 100% | 2023-02-22 | 2023-09-27 | 156d | 2023-02-22 | 2023-09-14 |  | N/A | N/A | Regulatory | M6 | 5.0 | N/A | Regulatory |  |  |  |  |  |  |
| 2333 | 1.7.1.2.3.1 | Pre Code Drafting activities |  | 5d | 2023-02-22 A | 2023-02-28 A | 2334SS-5d | 100% | 2023-02-22 | 2023-02-28 | 5d | 2023-02-22 | 2023-02-28 |  | Code Drafting PM |  | Regulatory |  | 5.0 | Andrew Margan | Regulatory | Complete | COMPLETE |  |  |  |  |
| 2334 | 1.7.1.2.3.2 | Code Drafting (offline) |  | 80d | 2023-03-01 A | 2023-06-20 A | 2318SS | 100% | 2023-03-01 | 2023-06-20 | 80d | 2023-03-01 | 2023-06-20 | must start on 2023-03-01 | Code Bodies,SRO Design | Code Drafting PM | Regulatory |  | 5.0 | Andrew Margan | Regulatory | Complete | COMPLETE |  |  |  |  |
| 2335 | 1.7.1.2.3.3 | Internal review and cross-checking of drafting across code drafters |  | 70d | 2023-03-15 A | 2023-06-20 A | 2334SS+10d | 100% | 2023-03-15 | 2023-06-20 | 70d | 2023-03-15 | 2023-06-20 |  | Code Bodies,SRO Design | Code Drafting PM | Regulatory |  | 5.0 | Andrew Margan | Regulatory | Complete | COMPLETE |  |  |  |  |
| 2336 | 1.7.1.2.3.4 | External industry review via consultation |  | 15d | 2023-06-21 A | 2023-07-11 A | 2335 | 100% | 2023-06-21 | 2023-07-11 | 15d | 2023-06-21 | 2023-07-11 |  | PP | Code Drafting PM | Regulatory |  | 5.0 | Andrew Margan | Regulatory | Complete | COMPLETE |  |  |  |  |
| 2337 | 1.7.1.2.3.5 | Triage and action comments |  | 19d | 2023-07-10 A | 2023-08-03 A | 2336FS-2d | 100% | 2023-07-10 | 2023-08-03 | 19d | 2023-07-10 | 2023-08-03 |  | Code Bodies,SRO Design | Code Drafting PM | Regulatory |  | 5.0 | Andrew Margan | Regulatory | Complete | COMPLETE |  |  |  |  |
| 2338 | 1.7.1.2.3.6 | CDWG review |  | 28d | 2023-08-04 A | 2023-09-12 A | 2337 | 100% | 2023-08-04 | 2023-09-12 | 28d | 2023-08-04 | 2023-09-07 |  | PP | Code Drafting PM | Regulatory |  | 5.0 | Andrew Margan | Regulatory | Complete | COMPLETE |  |  |  |  |
| 2339 | 1.7.1.2.3.7 | CCAG review |  | 11d | 2023-09-13 A | 2023-09-27 A | 2338 | 100% | 2023-09-13 | 2023-09-27 | 11d | 2023-09-08 | 2023-09-14 |  | PP |  | Regulatory |  | 5.0 | Andrew Margan | Regulatory | Complete | COMPLETE |  |  |  |  |
| 2340 | 1.7.1.2.3.8 | Code drafting for BSC Central Services topic area approved | milestone | 0d | 2023-09-27 A | 2023-09-27 A | 2339 | 100% | 2023-09-27 | 2023-09-27 | 0d | 2023-09-14 | 2023-09-14 |  | PP | Code Drafting PM | Regulatory |  | 5.0 | Andrew Margan | Regulatory | Complete | COMPLETE | MHHS-ART060 | T2-RE-0200 | CCAG | T2 |
| 2341 | 1.7.1.2.4 | **Registration (BSC & REC driven)** |  | 131d | 2023-02-22 A | 2023-08-23 A |  | 100% | 2023-02-22 | 2023-08-23 | 131d | 2023-02-22 | 2023-08-23 |  | N/A | N/A | Regulatory | M6 | 5.0 | N/A | Regulatory |  |  |  |  |  |  |
| 2342 | 1.7.1.2.4.1 | Pre Code Drafting activities |  | 5d | 2023-02-22 A | 2023-02-28 A | 2343SS-5d | 100% | 2023-02-22 | 2023-02-28 | 5d | 2023-02-22 | 2023-02-28 |  | Code Drafting PM |  | Regulatory |  | 5.0 | Andrew Margan | Regulatory | Complete | COMPLETE |  |  |  |  |
| 2343 | 1.7.1.2.4.2 | Code Drafting (offline) |  | 65d | 2023-03-01 A | 2023-05-30 A | 2317, 2326 | 100% | 2023-03-01 | 2023-05-30 | 65d | 2023-03-01 | 2023-05-30 | must start on 2023-03-01 | Code Bodies,SRO Design | Code Drafting PM | Regulatory |  | 5.0 | Andrew Margan | Regulatory | Complete | COMPLETE |  |  |  |  |
| 2344 | 1.7.1.2.4.3 | Internal review and cross-checking of drafting across code drafters |  | 55d | 2023-03-15 A | 2023-05-30 A | 2343SS+10d | 100% | 2023-03-15 | 2023-05-30 | 55d | 2023-03-15 | 2023-05-30 |  | Code Bodies,SRO Design | Code Drafting PM | Regulatory |  | 5.0 | Andrew Margan | Regulatory | Complete | COMPLETE |  |  |  |  |
| 2345 | 1.7.1.2.4.4 | External industry review via consultation |  | 15d | 2023-05-31 A | 2023-06-20 A | 2344 | 100% | 2023-05-31 | 2023-06-20 | 15d | 2023-05-31 | 2023-06-20 |  | PP | Code Drafting PM | Regulatory |  | 5.0 | Andrew Margan | Regulatory | Complete | COMPLETE |  |  |  |  |
| 2346 | 1.7.1.2.4.5 | Triage and action comments |  | 19d | 2023-06-19 A | 2023-07-13 A | 2345FS-2d | 100% | 2023-06-19 | 2023-07-13 | 19d | 2023-06-19 | 2023-07-13 |  | Code Bodies,SRO Design | Code Drafting PM | Regulatory |  | 5.0 | Andrew Margan | Regulatory | Complete | COMPLETE |  |  |  |  |
| 2347 | 1.7.1.2.4.6 | CDWG review |  | 18d | 2023-07-14 A | 2023-08-08 A | 2346 | 100% | 2023-07-14 | 2023-08-08 | 18d | 2023-07-14 | 2023-08-16 |  | PP | Code Drafting PM | Regulatory |  | 5.0 | Andrew Margan | Regulatory | Complete | COMPLETE |  |  |  |  |
| 2348 | 1.7.1.2.4.7 | CCAG review |  | 11d | 2023-08-09 A | 2023-08-23 A | 2347 | 100% | 2023-08-09 | 2023-08-23 | 11d | 2023-08-17 | 2023-08-23 |  | PP |  | Regulatory |  | 5.0 | Andrew Margan | Regulatory | Complete | COMPLETE |  |  |  |  |
| 2349 | 1.7.1.2.4.8 | Code drafting for Registration topic area approved | milestone | 0d | 2023-08-23 A | 2023-08-23 A | 2348 | 100% | 2023-08-23 | 2023-08-23 | 0d | 2023-08-23 | 2023-08-23 |  | PP | Code Drafting PM | Regulatory |  | 5.0 | Andrew Margan | Regulatory | Complete | COMPLETE | MHHS-ART060 | T2-RE-0250 | CCAG | T2 |

| ID | WBS | Task | Type | Duration | Start | Finish | Predecessors | Complete | Baseline start | Baseline finish | Baseline duration | Baseline 1 start | Baseline 1 finish | Responsible | Involved | Text9 | Task Status | Update Version | MHHS Resource Name | MHHS Programme Phase | Sched Status | RAG | Artefact ID | Milestone ID | Text29 | Tier |
| --- | --- | --- | --- | --- | --- | --- | --- | --- | --- | --- | --- | --- | --- | --- | --- | --- | --- | --- | --- | --- | --- | --- | --- | --- | --- | --- |
| 2350 | 1.7.1.2.5 | **Governance and Qualification (BSC & REC driven)** |  | 130d | 2023-05-25 A | 2023-11-22 A |  | 100% | 2023-05-25 | 2023-11-22 | 130d | 2023-05-25 | 2023-11-13 | N/A | N/A | Regulatory | M6 | 5.0 | N/A | Regulatory |  |  |  |  |  |  |
| 2351 | 1.7.1.2.5.1 | Pre Code Drafting activities |  | 5d | 2023-05-25 A | 2023-05-31 A | 2352SS-5d | 100% | 2023-05-25 | 2023-05-31 | 5d | 2023-05-25 | 2023-05-31 | Code Drafting PM |  | Regulatory |  | 5.0 | Andrew Margan | Regulatory | Complete | COMPLETE |  |  |  |  |
| 2352 | 1.7.1.2.5.2 | Code Drafting (offline) |  | 55d | 2023-06-01 A | 2023-08-16 A | 2345SS+1d | 100% | 2023-06-01 | 2023-08-16 | 55d | 2023-06-01 | 2023-08-16 | Code Bodies,SRO Design | Code Drafting PM | Regulatory |  | 5.0 | Andrew Margan | Regulatory | Complete | COMPLETE |  |  |  |  |
| 2353 | 1.7.1.2.5.3 | Internal review and cross-checking of drafting across code drafters |  | 45d | 2023-06-15 A | 2023-08-16 A | 2352SS+10d | 100% | 2023-06-15 | 2023-08-16 | 45d | 2023-06-15 | 2023-08-16 | Code Bodies,SRO Design | Code Drafting PM | Regulatory |  | 5.0 | Andrew Margan | Regulatory | Complete | COMPLETE |  |  |  |  |
| 2354 | 1.7.1.2.5.4 | External industry review via consultation |  | 15d | 2023-08-18 A | 2023-09-07 A | 2353FS+1d | 100% | 2023-08-18 | 2023-09-07 | 15d | 2023-08-18 | 2023-09-07 | PP | Code Drafting PM | Regulatory |  | 5.0 | Andrew Margan | Regulatory | Complete | COMPLETE |  |  |  |  |
| 2355 | 1.7.1.2.5.5 | Triage and action comments |  | 19d | 2023-09-06 A | 2023-10-02 A | 2354FS-2d | 100% | 2023-09-06 | 2023-10-02 | 19d | 2023-09-06 | 2023-10-02 | Code Bodies,SRO Design | Code Drafting PM | Regulatory |  | 5.0 | Andrew Margan | Regulatory | Complete | COMPLETE |  |  |  |  |
| 2356 | 1.7.1.2.5.6 | CDWG review |  | 31d | 2023-10-03 A | 2023-11-14 A | 2355 | 100% | 2023-10-03 | 2023-11-14 | 31d | 2023-10-03 | 2023-11-06 | PP | Code Drafting PM | Regulatory |  | 5.0 | Andrew Margan | Regulatory | Complete | COMPLETE |  |  |  |  |
| 2357 | 1.7.1.2.5.7 | CCAG review |  | 6d | 2023-11-15 A | 2023-11-22 A | 2356 | 100% | 2023-11-15 | 2023-11-22 | 6d | 2023-11-07 | 2023-11-13 | PP |  | Regulatory |  | 5.0 | Andrew Margan | Regulatory | Complete | COMPLETE |  |  |  |  |
| 2358 | 1.7.1.2.5.8 | Code drafting for Governance and Qualification topic areas approved | milestone | 0d | 2023-11-22 A | 2023-11-22 A | 2357 | 100% | 2023-11-22 | 2023-11-22 | 0d | 2023-11-13 | 2023-11-13 | PP | Code Drafting PM | Regulatory |  | 5.12 | Andrew Margan | Regulatory | Complete | COMPLETE | MHHS-ART060 | T3-RE-0300 | CCAG | T2 |
| 2359 | 1.7.1.2.6 | **Interfaces / Data Specification (REC driven)** |  | 174d | 2023-05-25 A | 2024-01-23 A |  | 100% | 2023-05-25 | 2024-01-23 | 175d | 2023-05-25 | 2023-11-13 | N/A | N/A | Regulatory | M6 | 5.2 | N/A | Regulatory |  |  |  |  |  |  |
| 2360 | 1.7.1.2.6.1 | Pre Code Drafting activities |  | 5d | 2023-05-25 A | 2023-05-31 A | 2361SS-5d | 100% | 2023-05-25 | 2023-05-31 | 5d | 2023-05-25 | 2023-05-31 | Code Drafting PM |  | Regulatory |  | 5.0 | Andrew Margan | Regulatory | Complete | COMPLETE |  |  |  |  |
| 2361 | 1.7.1.2.6.2 | Code Drafting (offline) |  | 94d | 2023-06-01 A | 2023-10-10 A | 2345SS+1d | 100% | 2023-06-01 | 2023-10-10 | 94d | 2023-06-01 | 2023-08-16 | Code Bodies,SRO Design | Code Drafting PM | Regulatory |  | 5.2 | Andrew Margan | Regulatory | Complete | COMPLETE |  |  |  |  |
| 2362 | 1.7.1.2.6.3 | Internal review and cross-checking of drafting across code drafters |  | 84d | 2023-06-15 A | 2023-10-10 A | 2361SS+10d | 100% | 2023-06-15 | 2023-10-10 | 84d | 2023-06-15 | 2023-08-16 | Code Bodies,SRO Design | Code Drafting PM | Regulatory |  | 5.2 | Andrew Margan | Regulatory | Complete | COMPLETE |  |  |  |  |
| 2363 | 1.7.1.2.6.4 | External industry review via consultation |  | 15d | 2023-10-11 A | 2023-10-31 A | 2362 | 100% | 2023-10-11 | 2023-10-31 | 15d | 2023-08-18 | 2023-09-07 | PP | Code Drafting PM | Regulatory |  | 5.2 | Andrew Margan | Regulatory | Complete | COMPLETE |  |  |  |  |
| 2364 | 1.7.1.2.6.5 | Triage and action comments |  | 20d | 2023-10-30 A | 2023-11-24 A | 2363FS-2d | 100% | 2023-10-30 | 2023-11-24 | 20d | 2023-09-06 | 2023-10-02 | Code Bodies,SRO Design | Code Drafting PM | Regulatory |  | 5.2 | Andrew Margan | Regulatory | Complete | COMPLETE |  |  |  |  |
| 2365 | 1.7.1.2.6.6 | CDWG review |  | 37d | 2023-11-27 A | 2024-01-16 A | 2364 | 100% | 2023-11-27 | 2024-01-16 | 32d | 2023-10-03 | 2023-11-06 | PP | Code Drafting PM | Regulatory |  | 5.2 | Andrew Margan | Regulatory | Complete | COMPLETE |  |  |  |  |
| 2366 | 1.7.1.2.6.7 | CCAG review |  | 5d | 2024-01-17 A | 2024-01-23 A | 2365 | 100% | 2024-01-17 | 2024-01-23 | 11d | 2023-11-07 | 2023-11-13 | PP | Code Drafting PM | Regulatory |  | 5.2 | Andrew Margan | Regulatory | Complete | COMPLETE |  |  |  |  |
| 2367 | 1.7.1.2.6.8 | Code drafting for Interfaces / Data Specification topic areas approved | milestone | 0d | 2024-01-23 A | 2024-01-23 A | 2366 | 100% | 2024-01-23 | 2024-01-23 | 0d | 2023-11-13 | 2023-11-13 | PP | Code Drafting PM | Regulatory |  | 5.16 | Andrew Margan | Regulatory | Complete | COMPLETE | MHHS-ART060 | T3-RE-0350 | CCAG | T2 |
| 2368 | 1.7.1.2.7 | **Migration (BSC & REC driven)** |  | 130d | 2023-05-25 A | 2023-11-22 A |  | 100% | 2023-05-25 | 2023-11-22 | 130d | 2023-05-25 | 2023-11-13 | N/A | N/A | Regulatory | M6 | 5.0 | N/A | Regulatory |  |  |  |  |  |  |
| 2369 | 1.7.1.2.7.1 | Pre Code Drafting activities |  | 5d | 2023-05-25 A | 2023-05-31 A | 2370SS-5d | 100% | 2023-05-25 | 2023-05-31 | 5d | 2023-05-25 | 2023-05-31 | Code Drafting PM |  | Regulatory |  | 5.0 | Andrew Margan | Regulatory | Complete | COMPLETE |  |  |  |  |
| 2370 | 1.7.1.2.7.2 | Code Drafting (offline) |  | 55d | 2023-06-01 A | 2023-08-16 A | 2345SS+1d | 100% | 2023-06-01 | 2023-08-16 | 55d | 2023-06-01 | 2023-08-16 | Code Bodies,SRO Design | Code Drafting PM | Regulatory |  | 5.0 | Andrew Margan | Regulatory | Complete | COMPLETE |  |  |  |  |
| 2371 | 1.7.1.2.7.3 | Internal review and cross-checking of drafting across code drafters |  | 45d | 2023-06-15 A | 2023-08-16 A | 2370SS+10d | 100% | 2023-06-15 | 2023-08-16 | 45d | 2023-06-15 | 2023-08-16 | Code Bodies,SRO Design | Code Drafting PM | Regulatory |  | 5.0 | Andrew Margan | Regulatory | Complete | COMPLETE |  |  |  |  |
| 2372 | 1.7.1.2.7.4 | External industry review via consultation |  | 15d | 2023-08-18 A | 2023-09-07 A | 2371FS+1d | 100% | 2023-08-18 | 2023-09-07 | 15d | 2023-08-18 | 2023-09-07 | PP | Code Drafting PM | Regulatory |  | 5.0 | Andrew Margan | Regulatory | Complete | COMPLETE |  |  |  |  |
| 2373 | 1.7.1.2.7.5 | Triage and action comments |  | 19d | 2023-09-06 A | 2023-10-02 A | 2372FS-2d | 100% | 2023-09-06 | 2023-10-02 | 19d | 2023-09-06 | 2023-10-02 | Code Bodies,SRO Design | Code Drafting PM | Regulatory |  | 5.0 | Andrew Margan | Regulatory | Complete | COMPLETE |  |  |  |  |
| 2374 | 1.7.1.2.7.6 | CDWG review |  | 31d | 2023-10-03 A | 2023-11-14 A | 2373 | 100% | 2023-10-03 | 2023-11-14 | 31d | 2023-10-03 | 2023-11-06 | PP | Code Drafting PM | Regulatory |  | 5.0 | Andrew Margan | Regulatory | Complete | COMPLETE |  |  |  |  |
| 2375 | 1.7.1.2.7.7 | CCAG review |  | 6d | 2023-11-15 A | 2023-11-22 A | 2374 | 100% | 2023-11-15 | 2023-11-22 | 6d | 2023-11-07 | 2023-11-13 | PP | Code Drafting PM | Regulatory |  | 5.0 | Andrew Margan | Regulatory | Complete | COMPLETE |  |  |  |  |
| 2376 | 1.7.1.2.7.8 | Code drafting for Migration topic area approved | milestone | 0d | 2023-11-22 A | 2023-11-22 A | 2375 | 100% | 2023-11-22 | 2023-11-22 | 0d | 2023-11-13 | 2023-11-13 | PP | Code Drafting PM | Regulatory |  | 5.12 | Andrew Margan | Regulatory | Complete | COMPLETE | MHHS-ART060 | T3-RE-0400 | CCAG | T2 |

| ID | WBS | Task | Type | Duration | Start | Finish | Predecessors | Complete | Baseline start | Baseline finish | Baseline duration | Baseline 1 start | Baseline 1 finish | Constraint | Baseline cost | Responsible | Involved | Text9 | Update Version | MHHS Resource Name | MHHS Programme Phase | Sched Status | RAG | Task Status | Artefact ID | Milestone ID | Text29 | Tier |
| --- | --- | --- | --- | --- | --- | --- | --- | --- | --- | --- | --- | --- | --- | --- | --- | --- | --- | --- | --- | --- | --- | --- | --- | --- | --- | --- | --- | --- |
| 2377 | 1.7.1.2.8 | **Consequential Code Change** |  | 109d | 2023-10-11 A | 2024-03-11 A |  | 100% | 2023-10-11 | 2024-03-11 | 108d | 2023-08-18 | 2024-03-08 |  | -0 | N/A | N/A | Regulatory | 5.0 | N/A | Regulatory |  |  |  |  |  |  |  |
| 2378 | 1.7.1.2.8.1 | External industry review via consultation - drop 1 (DCUSA) |  | 15d | 2023-10-11 A | 2023-10-31 A | 2384SS | 100% | 2023-10-11 | 2023-10-31 | 15d | 2023-08-18 | 2023-09-07 |  |  | Code Bodies | PP | Regulatory | 5.2 | Andrew Margan | Regulatory | Complete | COMPLETE |  |  |  |  |  |
| 2379 | 1.7.1.2.8.2 | External industry review via consultation - drop 2 (Elexon) |  | 16d | 2024-02-19 A | 2024-03-11 A | 2394SS | 100% | 2024-02-19 | 2024-03-11 | 15d | 2023-10-16 | 2023-11-03 | start no earlier than 2024-02-19 |  | Code Bodies | PP | Regulatory | 5.2 | Andrew Margan | Regulatory | Complete | COMPLETE |  |  |  |  |  |
| 2380 | 1.7.1.2.9 | **Transition Text (all codes)** |  | 118d | 2023-08-11 A | 2024-01-23 A |  | 100% | 2023-08-11 | 2024-01-23 | 119d | 2023-08-11 | 2024-01-25 |  |  | N/A | N/A | Regulatory | 5.2 | N/A | Regulatory |  |  | M6 |  |  |  |  |
| 2381 | 1.7.1.2.9.1 | Pre Code Drafting activities |  | 8d | 2023-08-11 A | 2023-08-22 A | 2382SS-5d | 100% | 2023-08-11 | 2023-08-22 | 8d | 2023-08-11 | 2023-08-17 |  |  | Code Drafting PM |  | Regulatory | 5.0 | Andrew Margan | Regulatory | Complete | COMPLETE |  |  |  |  |  |
| 2382 | 1.7.1.2.9.2 | Code Drafting (offline) |  | 38d | 2023-08-18 A | 2023-10-10 A | 2372SS | 100% | 2023-08-18 | 2023-10-10 | 38d | 2023-08-18 | 2023-10-12 |  |  | Code Bodies,SRO Design | Code Drafting PM | Regulatory | 5.2 | Andrew Margan | Regulatory | Complete | COMPLETE |  |  |  |  |  |
| 2383 | 1.7.1.2.9.3 | Internal review and cross-checking of drafting across code drafters |  | 28d | 2023-09-01 A | 2023-10-10 A | 2382SS+10d | 100% | 2023-09-01 | 2023-10-10 | 28d | 2023-09-01 | 2023-10-12 |  |  | Code Bodies,SRO Design | Code Drafting PM | Regulatory | 5.2 | Andrew Margan | Regulatory | Complete | COMPLETE |  |  |  |  |  |
| 2384 | 1.7.1.2.9.4 | External industry review via consultation |  | 15d | 2023-10-11 A | 2023-10-31 A | 2383 | 100% | 2023-10-11 | 2023-10-31 | 15d | 2023-10-16 | 2023-11-03 |  |  | PP | Code Drafting PM | Regulatory | 5.2 | Andrew Margan | Regulatory | Complete | COMPLETE |  |  |  |  |  |
| 2385 | 1.7.1.2.9.5 | Triage and action comments |  | 20d | 2023-10-30 A | 2023-11-24 A | 2384FS-2d | 100% | 2023-10-30 | 2023-11-24 | 20d | 2023-11-02 | 2023-11-21 |  |  | Code Bodies,SRO Design | Code Drafting PM | Regulatory | 5.2 | Andrew Margan | Regulatory | Complete | COMPLETE |  |  |  |  |  |
| 2386 | 1.7.1.2.9.6 | CDWG review |  | 37d | 2023-11-27 A | 2024-01-16 A | 2385 | 100% | 2023-11-27 | 2024-01-16 | 37d | 2023-11-22 | 2024-01-17 |  |  | PP | Code Drafting PM | Regulatory | 5.2 | Andrew Margan | Regulatory | Complete | COMPLETE |  |  |  |  |  |
| 2387 | 1.7.1.2.9.7 | CCAG review |  | 5d | 2024-01-17 A | 2024-01-23 A | 2386 | 100% | 2024-01-17 | 2024-01-23 | 6d | 2024-01-18 | 2024-01-25 |  |  | PP | Code Drafting PM | Regulatory | 5.2 | Andrew Margan | Regulatory | Complete | COMPLETE |  |  |  |  |  |
| 2388 | 1.7.1.2.9.8 | Code drafting for Transition Text topic area approved | milestone | 0d | 2024-01-23 A | 2024-01-23 A | 2387 | 100% | 2024-01-23 | 2024-01-23 | 0d | 2024-01-25 | 2024-01-25 |  |  | PP | Code Drafting PM | Regulatory | 5.16 | Andrew Margan | Regulatory | Complete | COMPLETE |  | MHHS-ART060 | T3-RE-0450 | CCAG | T2 |
| 2389 | 1.7.1.2.10 | **Final Code Drafting (mop-up) (all codes)** |  | 199d | 2023-08-18 A | 2024-05-22 A |  | 100% | 2023-08-18 | 2024-05-22 | 199d | 2023-08-18 | 2024-05-13 |  |  | N/A | N/A | Regulatory | 5.0 | N/A | Regulatory |  |  | M6 |  |  |  |  |
| 2390 | 1.7.1.2.10.1 | Forward look and confirm remaining plan |  | 15d | 2023-08-18 A | 2023-09-07 A | 2382SS | 100% | 2023-08-18 | 2023-09-07 | 15d | 2023-08-18 | 2023-09-07 |  |  | Code Drafting PM |  | Regulatory | 5.0 | Andrew Margan | Regulatory | Complete | COMPLETE |  |  |  |  |  |
| 2391 | 1.7.1.2.10.2 | Identify remaining or additional areas of code (e.g. consequential change requirements) to be completed |  | 15d | 2023-08-18 A | 2023-09-07 A | 2390SS | 100% | 2023-08-18 | 2023-09-07 | 15d | 2023-08-18 | 2023-09-07 |  |  | Code Bodies,SRO Design | Code Drafting PM | Regulatory | 5.0 | Andrew Margan | Regulatory | Complete | COMPLETE |  |  |  |  |  |
| 2392 | 1.7.1.2.10.3 | Code Drafting (offline) Interim Consultation (1) |  | 60d | 2023-09-08 A | 2023-11-30 A | 2391 | 100% | 2023-09-08 | 2023-11-30 | 60d | 2023-09-08 | 2024-02-15 |  |  | Code Bodies,SRO Design | Code Drafting PM | Regulatory | 5.0 | Andrew Margan | Regulatory | Complete | COMPLETE |  |  |  |  |  |
| 2393 | 1.7.1.2.10.4 | Internal review and cross-checking of drafting across code drafters Interim Consultation (1) |  | 50d | 2023-09-22 A | 2023-11-30 A | 2392SS+10d | 100% | 2023-09-22 | 2023-11-30 | 50d | 2023-09-22 | 2024-02-15 |  |  | Code Bodies,SRO Design | Code Drafting PM | Regulatory | 5.0 | Andrew Margan | Regulatory | Complete | COMPLETE |  |  |  |  |  |
| 2394 | 1.7.1.2.10.5 | External industry review via consultation Interim Consultation (1) |  | 23d | 2023-12-01 A | 2024-01-02 A | 2393 | 100% | 2023-12-01 | 2024-01-02 | 23d | 2024-02-19 | 2024-03-08 |  |  | PP | Code Drafting PM | Regulatory | 5.0 | Andrew Margan | Regulatory | Complete | COMPLETE |  |  |  |  |  |
| 2395 | 1.7.1.2.10.6 | Code Drafting (offline) Final Consultation (2) |  | 55d | 2023-12-01 A | 2024-02-15 A | 2393 | 100% | 2023-12-01 | 2024-02-15 | 55d | 2023-09-08 | 2024-02-15 |  |  | Code Bodies,SRO Design | Code Drafting PM | Regulatory | 5.0 | Andrew Margan | Regulatory | Complete | COMPLETE |  |  |  |  |  |
| 2396 | 1.7.1.2.10.7 | Internal review and cross-checking of drafting across code drafters Final Consultation (2) |  | 45d | 2023-12-15 A | 2024-02-15 A | 2395SS+10d | 100% | 2023-12-15 | 2024-02-15 | 45d | 2023-09-22 | 2024-02-15 |  |  | Code Bodies,SRO Design | Code Drafting PM | Regulatory | 5.0 | Andrew Margan | Regulatory | Complete | COMPLETE |  |  |  |  |  |
| 2397 | 1.7.1.2.10.8 | External industry review via consultation Final Consultation (2) |  | 16d | 2024-02-19 A | 2024-03-11 A | 2396FS+1d | 100% | 2024-02-19 | 2024-03-11 | 15d | 2024-02-19 | 2024-03-08 |  |  | PP | Code Drafting PM | Regulatory | 5.0 | Andrew Margan | Regulatory | Complete | COMPLETE |  |  |  |  |  |
| 2398 | 1.7.1.2.10.9 | Triage and action comments |  | 18d | 2024-03-11 A | 2024-04-03 A | 2397FS-1d | 100% | 2024-03-11 | 2024-04-03 | 18d | 2024-03-07 | 2024-04-03 |  |  | Code Bodies,SRO Design | Code Drafting PM | Regulatory | 5.0 | Andrew Margan | Regulatory | Complete | COMPLETE |  |  |  |  |  |
| 2399 | 1.7.1.2.10.10 | CDWG review |  | 29d | 2024-04-04 A | 2024-05-14 A | 2398 | 100% | 2024-04-04 | 2024-05-14 | 31d | 2024-04-04 | 2024-05-03 |  |  | PP | Code Drafting PM | Regulatory | 5.0 | Andrew Margan | Regulatory | Complete | COMPLETE |  |  |  |  |  |
| 2400 | 1.7.1.2.10.11 | CCAG review |  | 6d | 2024-05-15 A | 2024-05-22 A | 2399 | 100% | 2024-05-15 | 2024-05-22 | 6d | 2024-05-06 | 2024-05-13 |  |  | PP | Code Drafting PM | Regulatory | 5.0 | Andrew Margan | Regulatory | Complete | COMPLETE |  |  |  |  |  |
| 2401 | 1.7.1.2.10.12 | Final code drafting (mop-up) approved | milestone | 0d | 2024-05-22 A | 2024-05-22 A | 2400 | 100% | 2024-05-22 | 2024-05-22 | 0d | 2024-05-13 | 2024-05-13 |  |  | PP | Code Drafting PM | Regulatory | 5.25 | Andrew Margan | Regulatory | Complete | COMPLETE |  | MHHS-ART060 | T3-RE-0500 | CCAG | T2 |

Notes:
- 2382: Guidance: 14/8/23 - RECCo transition drafting activity is expected to take the full 38 days, noting BSE co-drafting will be expected to take approx. 21 days

| ID | WBS | Task | Type | Duration | Start | Finish | Predecessors | Complete | Baseline start | Baseline finish | Baseline duration | Baseline 1 start | Baseline 1 finish | Baseline cost | Responsible | Involved | Text9 | Task Status | Update Version | MHHS Resource Name | MHHS Programme Phase | Sched Status | RAG | Artefact ID | Milestone ID | Text29 | Tier |
| --- | --- | --- | --- | --- | --- | --- | --- | --- | --- | --- | --- | --- | --- | --- | --- | --- | --- | --- | --- | --- | --- | --- | --- | --- | --- | --- | --- |
| 2402 | 1.7.1.2.11 | **Final code review, consistency check and approval** |  | 100d | 2024-04-04 A | 2024-08-21 A |  | 100% | 2024-04-04 | 2024-08-21 | 102d | 2024-05-06 | 2024-08-23 | -0 | N/A | N/A | Regulatory | M6 | 5.0 | N/A | Regulatory |  |  |  |  |  |  |
| 2403 | 1.7.1.2.11.1 | Gap analysis of final code against design artefacts (reverse process to code drafting) |  | 38d | 2024-04-04 A | 2024-05-27 A | 2399SS | 100% | 2024-04-04 | 2024-05-27 | 38d | 2024-05-06 | 2024-05-17 |  | Code Bodies,SRO Design | Code Drafting PM | Regulatory |  | 5.0 | Andrew Margan | Regulatory | Complete | COMPLETE |  |  |  |  |
| 2404 | 1.7.1.2.11.2 | Outputs of gap analysis actioned offline |  | 11d | 2024-05-28 A | 2024-06-11 A | 2403 | 100% | 2024-05-28 | 2024-06-11 | 11d | 2024-05-20 | 2024-06-07 |  | Code Bodies,SRO Design | Code Drafting PM | Regulatory |  | 5.0 | Andrew Margan | Regulatory | Complete | COMPLETE |  |  |  |  |
| 2405 | 1.7.1.2.11.3 | Final documentation collated for final consultation |  | 8d | 2024-06-12 A | 2024-06-21 A | 2404 | 100% | 2024-06-12 | 2024-06-21 | 9d | 2024-06-10 | 2024-06-13 |  | Code Drafting PM | Code Bodies,SRO Design | Regulatory |  | 5.23 | Andrew Margan | Regulatory | Complete | COMPLETE |  |  |  |  |
| 2406 | 1.7.1.2.11.4 | External industry review via consultation |  | 15d | 2024-06-24 A | 2024-07-12 A | 2405 | 100% | 2024-06-24 | 2024-07-12 | 20d | 2024-06-14 | 2024-07-04 |  | PP | Code Drafting PM | Regulatory |  | 5.0 | Andrew Margan | Regulatory | Complete | COMPLETE |  |  |  |  |
| 2407 | 1.7.1.2.11.5 | Triage and action comments |  | 10d | 2024-07-15 A | 2024-07-26 A | 2406 | 100% | 2024-07-15 | 2024-07-26 | 13d | 2024-07-03 | 2024-07-19 |  | Code Bodies,SRO Design | Code Drafting PM | Regulatory |  | 5.0 | Andrew Margan | Regulatory | Complete | COMPLETE |  |  |  |  |
| 2408 | 1.7.1.2.11.6 | Final CDWG review |  | 8d | 2024-08-02 A | 2024-08-13 A | 2407FS+4d | 100% | 2024-08-02 | 2024-08-13 | 6d | 2024-07-22 | 2024-08-16 |  | PP | Code Drafting PM | Regulatory |  | 5.0 | Andrew Margan | Regulatory | Complete | COMPLETE |  |  |  |  |
| 2409 | 1.7.1.2.11.7 | Final CCAG review |  | 6d | 2024-08-14 A | 2024-08-21 A | 2408 | 100% | 2024-08-14 | 2024-08-21 | 8d | 2024-08-19 | 2024-08-23 |  | PP | Code Drafting PM | Regulatory |  | 5.0 | Andrew Margan | Regulatory | Complete | COMPLETE |  |  |  |  |
| 2410 | 1.7.1.2.11.8 | CCAG recommend final code to PSG for baselining | milestone | 0d | 2024-08-21 A | 2024-08-21 A | 2409 | 100% | 2024-08-21 | 2024-08-21 | 0d | 2024-08-23 | 2024-08-23 |  | PP | Code Drafting PM | Regulatory |  | 5.9 | Andrew Margan | Regulatory | Complete | COMPLETE | MHHS-ART060 | T3-RE-0550 | CCAG | T2 |
| 2411 | 1.7.1.3 | Code changes baselined (M6) | milestone | 0d | 2024-08-23 A | 2024-08-23 A | 2409FS+2d, 2401, 2388, 2376, 2367, 2358, 2349, 2340, 2331, 2322 | 100% | 2024-08-23 | 2024-08-23 | 0d | 2024-08-23 | 2024-08-23 |  | CPT | PP | Regulatory |  | 5.0 | Andrew Margan | Regulatory | Complete | COMPLETE | MHHS-ART012 | T1-RE-1000 | PSG | T1 |
| 2412 | 1.7.2 | **Ofgem preparation and enactment of SCR powers** |  | 225d | 2024-02-05 A | 2024-12-13 A |  | 100% | 2024-02-05 | 2024-12-13 | 225d | 2024-01-26 | 2024-11-12 | -0 | N/A | N/A | Regulatory | M7 | 5.0 | N/A | Regulatory |  |  |  |  |  |  |
| 2413 | 1.7.2.1 | **Preparation and enactment of SCR Powers** |  | 223d | 2024-02-05 A | 2024-12-11 A |  | 100% | 2024-02-05 | 2024-12-11 | 223d | 2024-01-26 | 2024-11-11 | -0 | N/A | N/A | Regulatory |  | 5.0 | N/A | Regulatory |  |  |  |  |  |  |
| 2414 | 1.7.2.1.1 | Ofgem to keep Ofgem legal informed of process followed and nature of Code drafting to ensure that prepared for SCR go/no go decision |  | 101d | 2024-02-05 A | 2024-06-24 A | 2415SF | 100% | 2024-02-05 | 2024-06-24 | 101d | 2024-01-26 | 2024-06-14 |  | Ofgem | Code Bodies | Regulatory |  | 5.0 | Andrew Margan | Regulatory | Complete | COMPLETE |  |  |  |  |
| 2415 | 1.7.2.1.2 | OFGEM Legal to review Code Artefacts deliver policy intent and process followed and confirm that SCR powers are appropriate to use rather than SMAP - SCR go/no go |  | 14d | 2024-06-24 A | 2024-07-11 A | 2406SS | 100% | 2024-06-24 | 2024-07-11 | 15d | 2024-06-14 | 2024-07-04 |  | Ofgem | Code Bodies | Regulatory |  | 5.0 | Andrew Margan | Regulatory | Complete | COMPLETE |  |  |  |  |
| 2416 | 1.7.2.1.3 | Code Bodies to draft MOD proposal forms |  | 20d | 2024-07-12 A | 2024-08-08 A | 2415 | 100% | 2024-07-12 | 2024-08-08 | 20d | 2024-07-05 | 2024-08-01 |  | Code Bodies | Ofgem | Regulatory |  | 5.0 | Andrew Margan | Regulatory | Complete | COMPLETE |  |  |  |  |
| 2417 | 1.7.2.1.4 | Ofgem discuss and agree code mod timetable with code bodies (and MHHSP in relation to the dates for expected decisions) |  | 20d | 2024-07-12 A | 2024-08-08 A | 2415 | 100% | 2024-07-12 | 2024-08-08 | 20d | 2024-07-05 | 2024-08-01 |  | Ofgem | Code Bodies | Regulatory |  | 5.0 | Andrew Margan | Regulatory | Complete | COMPLETE |  |  |  |  |
| 2418 | 1.7.2.1.5 | Ofgem to publish each Direction to each code body specifying the timetable for each modification |  | 1d | 2024-08-28 A | 2024-08-28 A | 2417FS+13d | 100% | 2024-08-28 | 2024-08-28 | 1d | 2024-08-28 | 2024-08-28 |  | Ofgem | Code Bodies | Regulatory |  | 5.0 | Andrew Margan | Regulatory | Complete | COMPLETE |  |  |  |  |
| 2419 | 1.7.2.1.6 | Formally submit (by separate email) Modification Proposal Forms and legal texts to each code body |  | 1d | 2024-08-28 A | 2024-08-28 A | 2417FS+13d | 100% | 2024-08-28 | 2024-08-28 | 1d | 2024-08-28 | 2024-08-28 |  | Ofgem | Code Bodies | Regulatory |  | 5.0 | Andrew Margan | Regulatory | Complete | COMPLETE |  |  |  |  |
| 2420 | 1.7.2.1.7 | Each Code Body publishes and issues Modification Proposal Forms |  | 3d | 2024-08-29 A | 2024-09-02 A | 2419, 2418 | 100% | 2024-08-29 | 2024-09-02 | 3d | 2024-08-29 | 2024-09-02 |  | Code Bodies | Ofgem | Regulatory |  | 5.0 | Andrew Margan | Regulatory | Complete | COMPLETE |  |  |  |  |
| 2421 | 1.7.2.1.8 | Each Code Body sends Modification Proposal Forms to Panel to approve Mod to go to consultation |  | 10d | 2024-09-03 A | 2024-09-16 A | 2420 | 100% | 2024-09-03 | 2024-09-16 | 10d | 2024-09-03 | 2024-09-16 |  | Code Bodies | Ofgem | Regulatory |  | 5.0 | Andrew Margan | Regulatory | Complete | COMPLETE |  |  |  |  |
| 2422 | 1.7.2.1.9 | Modification Proposal approved by Panel for Consultation |  | 1d | 2024-09-17 A | 2024-09-17 A | 2421 | 100% | 2024-09-17 | 2024-09-17 | 1d | 2024-09-17 | 2024-09-17 |  | Code Bodies | Ofgem | Regulatory |  | 5.0 | Andrew Margan | Regulatory | Complete | COMPLETE |  |  |  |  |
| 2423 | 1.7.2.1.10 | Draft Modification Report issued for consultation |  | 1d | 2024-09-18 A | 2024-09-18 A | 2422 | 100% | 2024-09-18 | 2024-09-18 | 1d | 2024-09-18 | 2024-09-18 |  | Code Bodies | Ofgem | Regulatory |  | 5.0 | Andrew Margan | Regulatory | Complete | COMPLETE |  |  |  |  |
| 2424 | 1.7.2.1.11 | Consultation Close-out for representations |  | 15d | 2024-09-19 A | 2024-10-09 A | 2423 | 100% | 2024-09-19 | 2024-10-09 | 15d | 2024-09-19 | 2024-10-09 |  | Code Bodies | Ofgem | Regulatory |  | 5.0 | Andrew Margan | Regulatory | Complete | COMPLETE |  |  |  |  |
| 2425 | 1.7.2.1.12 | Each Code Body reviews consultation response and drafts Modification Report |  | 10d | 2024-10-10 A | 2024-10-23 A | 2424 | 100% | 2024-10-10 | 2024-10-23 | 10d | 2024-10-10 | 2024-10-23 |  | Code Bodies | Ofgem | Regulatory |  | 5.0 | Andrew Margan | Regulatory | Complete | COMPLETE |  |  |  |  |
| 2426 | 1.7.2.1.13 | Final Modification Report sent to Panel for decision with recommendation to approve |  | 1d | 2024-10-24 A | 2024-10-24 A | 2425 | 100% | 2024-10-24 | 2024-10-24 | 1d | 2024-10-24 | 2024-10-24 |  | Code Bodies | Ofgem | Regulatory |  | 6.11 | Andrew Margan | Regulatory | Complete | COMPLETE |  |  |  |  |
| 2427 | 1.7.2.1.14 | Modification Panel decision |  | 1d | 2024-11-07 A | 2024-11-07 A | 2426FS+9d | 100% | 2024-11-07 | 2024-11-07 | 1d | 2024-11-07 | 2024-11-07 |  | Code Bodies | Ofgem | Regulatory |  | 6.11 | Andrew Margan | Regulatory | Complete | COMPLETE |  |  |  |  |
| 2428 | 1.7.2.1.15 | Code Bodies Submit Final Modification/Change Reports |  | 1d | 2024-11-08 A | 2024-11-08 A | 2427 | 100% | 2024-11-08 | 2024-11-08 | 1d |  |  |  | Code Bodies | Ofgem | Regulatory |  | 6.11 | Andrew Margan |  | Complete | COMPLETE |  |  |  |  |
| 2429 | 1.7.2.1.16 | Ofgem Reviews Final Modification/Change Reports |  | 10d | 2024-11-11 A | 2024-11-22 A | 2428 | 100% | 2024-11-11 | 2024-11-22 | 10d |  |  |  | Ofgem | Code Bodies | Regulatory |  | 6.11 | Andrew Margan |  | Complete | COMPLETE |  |  |  |  |
| 2430 | 1.7.2.1.17 | Ofgem Drafts Decision/Direction Letters |  | 17d | 2024-11-18 A | 2024-12-10 A | 2429SS+5d | 100% | 2024-11-18 | 2024-12-10 | 17d |  |  |  | Ofgem | Code Bodies | Regulatory |  | 6.11 | Andrew Margan |  | Complete | COMPLETE |  |  |  |  |
| 2431 | 1.7.2.1.18 | Ofgem Internally Signs Off the Decision/Direction Letters and Sends Them to the Code Bodies |  | 1d | 2024-12-11 A | 2024-12-11 A | 2430 | 100% | 2024-12-11 | 2024-12-11 | 1d |  |  |  | Ofgem | Code Bodies | Regulatory |  | 6.11 | Andrew Margan |  | Complete | COMPLETE |  |  |  |  |
| 2432 | 1.7.2.2 | Ofgem decisions on M6 baselined code modification proposals (M7) | milestone | 0d | 2024-12-11 A | 2024-12-11 A | 2411, 2431 | 100% | 2024-12-11 | 2024-12-11 | 0d | 2024-11-11 | 2024-11-11 |  | CPT | PP | Regulatory |  | 6.11 | Andrew Margan | Regulatory | Complete | COMPLETE | MHHS-ART012 | T2-RE-0600 | CCAG | T2 |
| 2433 | 1.7.2.3 | Ofgem Publishes the Decisions/Directions |  | 2d | 2024-12-12 A | 2024-12-13 A | 2432 | 100% | 2024-12-12 | 2024-12-13 | 2d |  |  |  | Ofgem | Code Bodies | Regulatory |  | 6.11 | Andrew Margan |  | Complete | COMPLETE |  |  |  |  |

Notes:
- 2432: Guidance: 5/8/25 - CR no52 and going to PSG on 7/8/24. 21/8/24: Milestone name and date change approved at psg on 7/8/24

| ID | WBS | Task | Type | Duration | Start | Finish | Predecessors | Complete | Remaining | Baseline start | Baseline finish | Baseline duration | Baseline 1 start | Baseline 1 finish | Total slack | Free slack | Constraint | Baseline cost | Responsible | Involved | Text9 | Task Status | Update Version | MHHS Resource Name | MHHS Programme Phase | Sched Status | RAG | Artefact ID | Milestone ID | Text29 | Tier | Future RAG |
| --- | --- | --- | --- | --- | --- | --- | --- | --- | --- | --- | --- | --- | --- | --- | --- | --- | --- | --- | --- | --- | --- | --- | --- | --- | --- | --- | --- | --- | --- | --- | --- | --- |
| 2434 | 1.7.3 | **Deliver MHHS Code Changes** |  | 292d | 2024-11-12 A | 2025-12-24 |  | 84% | 47.97d | 2024-11-12 | 2025-12-24 | 149d | 2024-11-12 | 2025-03-07 | 32094d |  |  |  | N/A | N/A | Regulatory | M8 | 6.11 | N/A | Regulatory |  |  |  |  |  |  |  |
| 2435 | 1.7.3.1 | **Releases** |  | 292d | 2024-11-12 A | 2025-12-24 |  | 84% | 47.97d | 2024-11-12 | 2025-12-24 | 149d | 2024-11-12 | 2025-03-07 | 32094d |  |  |  | N/A | N/A | Regulatory |  | 6.11 | N/A | Regulatory |  |  |  |  |  |  |  |
| 2436 | 1.7.3.1.1 | Impacted codes make resourcing provisions and prepare to implement new Code via internal code body change processes |  | 78d | 2024-11-12 A | 2025-02-27 |  | 90% | 7.8d | 2024-11-12 | 2025-02-27 | 78d | 2024-11-12 | 2025-02-27 | 32308d |  | start no earlier than 2024-11-12 |  | Code Bodies |  | Regulatory |  | 6.11 | Andrew Margan | Regulatory | Green | GREEN |  |  |  |  |  |
| 2437 | 1.7.3.1.2 | **Main Code Release** |  | 71d | 2025-09-17 | 2025-12-24 |  |  |  | 2025-09-17 | 2025-12-24 | 71d | 2025-02-28 | 2025-03-07 | 32094d |  |  |  | N/A | N/A | Regulatory |  | 6.11 | N/A | Regulatory |  |  |  |  |  |  |  |
| 2438 | 1.7.3.1.2.1 | Release preparation (e.g. preparing release documentation) |  | 6d | 2025-09-17 | 2025-09-24 | 2439SF |  |  | 2025-09-17 | 2025-09-24 | 5d | 2025-02-28 | 2025-03-07 | 32159d |  |  |  | Code Bodies |  | Regulatory | 271.33 | 6.11 | Andrew Margan | Regulatory | Green | GREEN |  |  |  |  |  |
| 2439 | 1.7.3.1.2.2 | Implement new code on day of code release | milestone | 0d | 2025-09-24 | 2025-09-24 | 2440SF |  |  | 2025-09-24 | 2025-09-24 | 1d | 2025-03-07 | 2025-03-07 | 32159d | 0d |  |  | Code Bodies |  | Regulatory | 278.71 | 6.11 | Andrew Margan | Regulatory | Green | GREEN |  |  |  |  |  |
| 2440 | 1.7.3.1.2.3 | Code changes delivered (M8) | milestone | 0d | 2025-09-24 | 2025-09-24 | 2432, 2411, 1774SS |  |  | 2025-09-24 | 2025-09-24 | 0d | 2025-03-07 | 2025-03-07 | 32094d | 0d |  |  | CPT | Code Bodies,PP | Regulatory | 278.71 | 6.11 | Andrew Margan | Regulatory | Green | GREEN | MHHS-ART060 | T2-RE-0650 | CCAG | T2 |  |
| 2441 | 1.7.3.1.2.4 | Code changes delivered (M8*) late exit | milestone | 0d | 2025-12-24 | 2025-12-24 | 2440FS+65d |  |  | 2025-12-24 | 2025-12-24 | 0d |  |  | 32094d |  |  |  | CPT | Code Bodies,PP | Regulatory | 369.71 | 6.11 | Andrew Margan | Regulatory | Green | GREEN | MHHS-ART060 | T2-RE-0700 | CCAG | T2 |  |
| 2442 | 1.7.4 | **External Programme Dependency Management** |  | 38d | 2023-12-01 A | 2024-01-24 A |  | 100% |  | 2023-12-01 | 2024-01-24 | 38d | 2023-09-08 | 2024-01-24 |  |  |  |  | N/A | N/A | Regulatory |  | 5.0 | N/A | Regulatory |  |  |  |  |  |  |  |
| 2443 | 1.7.4.1 | **DCP397** |  | 38d | 2023-12-01 A | 2024-01-24 A |  | 100% |  | 2023-12-01 | 2024-01-24 | 38d | 2023-09-08 | 2024-01-24 |  |  |  |  | N/A | N/A | Regulatory |  | 5.0 | N/A | Regulatory |  |  |  |  |  |  |  |
| 2444 | 1.7.4.1.1 | Ensure DCP397 drafting included in mop-up code drafting activity (link to mop-up) |  | 20d | 2023-12-01 A | 2023-12-28 A | 2395SS, 2392SS | 100% |  | 2023-12-01 | 2023-12-28 | 20d | 2023-09-08 | 2023-10-05 |  |  |  |  | CPT | Code Bodies,SRO Design, Code Drafting PM | Regulatory |  | 5.0 | Andrew Margan | Regulatory | Complete | COMPLETE |  |  |  |  |  |
| 2445 | 1.7.4.1.2 | Implementation of DCP397 | milestone | 0d | 2024-01-24 A | 2024-01-24 A |  | 100% |  | 2024-01-24 | 2024-01-24 | 0d | 2024-01-24 | 2024-01-24 |  |  | start no earlier than 2024-01-24 |  | Code Bodies |  | Regulatory |  | 5.0 | Andrew Margan | Regulatory | Complete | COMPLETE |  |  |  |  |  |
| 2446 | 1.8 | **MIGRATION** |  | 1246d? | 2022-10-31 A | 2027-08-09 |  | 36% | 793.67d? | 2022-10-31 | 2027-08-09 | 1092d | 2022-10-31 | 2027-01-05 | 31671d |  |  | -0 | N/A | N/A | Migration |  |  | N/A | Migration |  |  |  |  |  |  | 1 Oct 2024 - 31 Oct 2025 |
| 2447 | 1.8.1 | Migration Period Plan Review 1 Completed | milestone | 0d | 2025-01-31 | 2025-01-31 |  |  |  | 2025-01-31 | 2025-01-31 | 0d | 2025-01-31 | 2025-01-31 | 32327d |  | finish no earlier than 2025-01-31 |  | SRO | PP,IPA | Migration | 42.71 | 5.28 | Warren Fulton | Migration | Green | GREEN |  | T3-MI-0016 | MCAG (Migration) | T3 |  |
| 2448 | 1.8.2 | **Regulatory Governance** |  | 198d | 2024-04-01 A | 2025-01-01 |  | 47% | 105d | 2024-04-01 | 2025-01-01 | 173d |  |  | 32349d |  |  | -0 | N/A | N/A | Migration |  | 5.28 | Warren Fulton |  |  |  |  |  |  |  |  |
| 2449 | 1.8.2.1 | Incentive Mods Created |  | 110d | 2024-04-01 A | 2024-08-30 |  | 85% | 17d | 2024-04-01 | 2024-08-30 | 85d |  |  | 32349d | 0d | start no earlier than 2024-04-01 |  | SRO Migration | SRO Migration,Code Bodies,PP | Migration |  | 5.28 | Warren Fulton |  | Overdue | RED |  |  |  |  |  |
| 2450 | 1.8.2.2 | Incentives Implemented |  | 88d | 2024-09-02 | 2025-01-01 | 2449 |  |  | 2024-09-02 | 2025-01-01 | 88d |  |  | 32349d |  | start no earlier than 2024-07-02 |  | Code Bodies | Code Bodies,SRO Migration | Migration | -108.67 | 5.28 | Warren Fulton |  | Overdue Start | GREEN |  |  |  |  |  |
| 2451 | 1.8.3 | **Migration Framework Agreed and Implemented** |  | 330d? | 2024-02-01 A | 2025-05-07 |  | 52% | 158.76d? | 2024-02-01 | 2025-01-23 | 214d |  |  | 32259d |  |  | -0 | N/A | N/A | Migration |  | 5.28 | Warren Fulton |  |  |  |  |  |  |  |  |
| 2452 | 1.8.3.1 | **Consultation 1 - Schedule** |  | 70d | 2024-02-01 A | 2024-05-08 A |  | 100% |  | 2024-02-01 | 2024-05-08 | 70d |  |  |  |  |  |  | N/A | N/A | Migration |  | 5.28 | Warren Fulton |  |  |  |  |  |  |  |  |
| 2453 | 1.8.3.1.1 | Prepare Artefacts for Consultation |  | 33d | 2024-02-01 A | 2024-03-18 A |  | 100% |  | 2024-02-01 | 2024-03-18 | 33d |  |  |  |  |  |  |  |  | Migration |  | 5.28 | Warren Fulton |  | Complete | COMPLETE |  |  |  |  |  |
| 2454 | 1.8.3.1.2 | Industry Consultation |  | 16d | 2024-03-18 A | 2024-04-08 A |  | 100% |  | 2024-03-18 | 2024-04-08 | 16d |  |  |  |  |  |  |  |  | Migration |  | 5.28 | Warren Fulton |  | Complete | COMPLETE |  |  |  |  |  |
| 2455 | 1.8.3.1.3 | Triage and Action Comments |  | 10d | 2024-04-08 A | 2024-04-19 A |  | 100% |  | 2024-04-08 | 2024-04-19 | 10d |  |  |  |  |  |  |  |  | Migration |  | 5.28 | Warren Fulton |  | Complete | COMPLETE |  |  |  |  |  |
| 2456 | 1.8.3.1.4 | Industry Assurance Review |  | 6d | 2024-04-19 A | 2024-04-26 A |  | 100% |  | 2024-04-19 | 2024-04-26 | 6d |  |  |  |  |  |  |  |  | Migration |  | 5.28 | Warren Fulton |  | Complete | COMPLETE |  |  |  |  |  |
| 2457 | 1.8.3.1.5 | MWG Recommendation |  | 1d | 2024-04-26 A | 2024-04-26 A |  | 100% |  | 2024-04-26 | 2024-04-26 | 1d |  |  |  |  |  |  |  |  | Migration |  | 5.28 | Warren Fulton |  | Complete | COMPLETE |  |  |  |  |  |
| 2458 | 1.8.3.1.6 | MCAG Interim Approval Artefacts |  | 1d | 2024-05-08 A | 2024-05-08 A |  | 100% |  | 2024-05-08 | 2024-05-08 | 1d |  |  |  |  |  |  |  |  | Migration |  | 5.28 | Warren Fulton |  | Complete | COMPLETE |  |  |  |  |  |

Notes:
- 2447: 27/11/24 - To go to MCAG for removal because milestone no longer reflects the delivery of the migration approach. / Action: 11/7/24: MI-0016 warren is saying he wants another think about before going to MCAG so can you hold off doing anything official with that one please?
- 2449: Potential to extend this to end of the year

| ID | WBS | Task | Type | Duration | Start | Finish | Predecessors | Complete | Remaining | Baseline start | Baseline finish | Baseline duration | Total slack | Free slack | Constraint | Baseline cost | Responsible | Involved | Text9 | Update Version | MHHS Resource Name | Sched Status | RAG | Milestone ID | Text29 | Tier | Task Status |
| --- | --- | --- | --- | --- | --- | --- | --- | --- | --- | --- | --- | --- | --- | --- | --- | --- | --- | --- | --- | --- | --- | --- | --- | --- | --- | --- | --- |
| 2459 | 1.8.3.2 | **Consultation 2 - Control** |  | 79d | 2024-04-08 A | 2024-07-25 A |  | 100% |  | 2024-04-08 | 2024-07-25 | 79d |  |  |  | -0 | N/A | N/A | Migration | 5.28 | Warren Fulton |  |  |  |  |  |  |
| 2460 | 1.8.3.2.1 | Prepare Artefacts for Consultation |  | 49d | 2024-04-08 A | 2024-06-13 A |  | 100% |  | 2024-04-08 | 2024-06-13 | 49d |  |  |  |  |  |  | Migration | 5.28 | Warren Fulton | Complete | COMPLETE |  |  |  |  |
| 2461 | 1.8.3.2.2 | Industry Consultation |  | 11d | 2024-06-14 A | 2024-06-28 A | 2460 | 100% |  | 2024-06-14 | 2024-06-28 | 11d |  |  |  |  |  |  | Migration | 5.28 | Warren Fulton | Complete | COMPLETE |  |  |  |  |
| 2462 | 1.8.3.2.3 | Triage and Action Comments |  | 9d | 2024-07-01 A | 2024-07-11 A | 2461 | 100% |  | 2024-07-01 | 2024-07-11 | 9d |  |  |  |  | SRO Migration | SRO Migration | Migration | 5.28 | Warren Fulton | Complete | COMPLETE |  |  |  |  |
| 2463 | 1.8.3.2.4 | Industry Assurance Review |  | 5d | 2024-07-12 A | 2024-07-18 A | 2462 | 100% |  | 2024-07-12 | 2024-07-18 | 5d |  |  |  |  | PP | PP,SRO Migration | Migration | 5.28 | Warren Fulton | Complete | COMPLETE |  |  |  |  |
| 2464 | 1.8.3.2.5 | MWG Recommendation | milestone | 0d | 2024-07-18 A | 2024-07-18 A | 2463 | 100% |  | 2024-07-18 | 2024-07-18 | 0d |  |  |  |  | PP | PP,SRO Migration | Migration | 5.28 | Warren Fulton | Complete | COMPLETE |  |  |  |  |
| 2465 | 1.8.3.2.6 | Consultation 2 - Control - MCAG Approval of Interim Artefacts | milestone | 0d | 2024-07-25 A | 2024-07-25 A | 2464FS+5d | 100% |  | 2024-07-25 | 2024-07-25 | 0d |  |  |  |  | PP | PP,SRO Migration | Migration | 5.30 | Warren Fulton | Complete | COMPLETE | T3-MI-0037 | MCAG (Migration) | T3 |  |
| 2466 | 1.8.3.3 | **Consultation 3 - Parameters** |  | 72d | 2024-11-18 A | 2025-02-25 |  | 40% | 42.91d | 2024-11-18 | 2025-02-25 | 76d | 32222d |  |  | -0 | N/A | N/A | Migration | 6.14 | Warren Fulton |  |  |  |  |  |  |
| 2467 | 1.8.3.3.1 | Prepare Artefacts for Consultation |  | 24d | 2024-11-18 A | 2024-12-19 A |  | 100% |  | 2024-11-18 | 2024-12-19 | 36d |  |  |  |  | SRO Migration | SRO Migration | Migration | 6.14 | Warren Fulton | Complete | COMPLETE |  |  |  |  |
| 2468 | 1.8.3.3.2 | Industry Consultation |  | 21d | 2024-12-20 A | 2025-01-17 | 2467 | 5% | 19.95d | 2024-12-20 | 2025-01-17 | 10d | 32222d | 0d |  |  | PP | PP,SRO Migration | Migration | 6.14 | Warren Fulton | Green | GREEN |  |  |  |  |
| 2469 | 1.8.3.3.3 | Triage Response |  | 10d | 2025-01-20 | 2025-01-31 | 2468 |  |  | 2025-01-20 | 2025-01-31 | 10d | 32222d | 0d |  |  | SRO Migration | SRO Migration | Migration | 6.14 | Warren Fulton | Green | GREEN |  |  |  | 31.33 |
| 2470 | 1.8.3.3.4 | Industry Assurance Review |  | 7d | 2025-02-03 | 2025-02-11 | 2469 |  |  | 2025-02-03 | 2025-02-11 | 7d | 32222d | 0d |  |  | PP | PP,SRO Migration | Migration | 6.14 | Warren Fulton | Green | GREEN |  |  |  | 45.33 |
| 2471 | 1.8.3.3.5 | MWG Recommendation | milestone | 0d | 2025-02-21 | 2025-02-21 | 2470FS+8d |  |  | 2025-02-21 | 2025-02-21 | 0d | 32222d | 0d |  |  | PP | PP,SRO Migration | Migration | 6.14 | Warren Fulton | Green | GREEN |  |  |  | 63.71 |
| 2472 | 1.8.3.3.6 | MCAG Paper Day | milestone | 0d | 2025-02-25 | 2025-02-25 | 2471FS+2d |  |  | 2025-02-25 | 2025-02-25 | 0d | 32222d | 0d |  |  |  |  | Migration | 6.14 | Warren Fulton | Green | GREEN |  |  |  | 67.71 |
| 2473 | 1.8.3.3.7 | MCAG Approval of Migration Framework Artefacts (Baselined) | milestone | 0d | 2025-02-25 | 2025-02-25 | 2486, 2471, 2472 |  |  | 2025-02-25 | 2025-02-25 | 0d | 32222d | 0d |  |  | PP | PP,SRO Migration | Migration | 6.14 | Warren Fulton | Green | GREEN | T3-MI-0017 | MCAG (Migration) | T3 | 67.71 |
| 2474 | 1.8.3.4 | **Consultation 4** |  | 87d? | 2025-01-07 | 2025-05-07 |  |  |  | 2025-01-07 | 2025-05-07 |  | 32259d |  |  |  | SI Migration |  | Migration | 6.14 | Warren Fulton | Overdue Start | RED |  |  |  | -770.67 |
| 2475 | 1.8.3.4.1 | **Prepare Artefacts** |  | 87d? | 2025-01-07 | 2025-05-07 |  |  |  | 2025-01-07 | 2025-05-07 |  | 32259d |  |  |  | SI Migration |  | Migration | 6.14 | Warren Fulton | Overdue Start | RED |  |  |  | -770.67 |
| 2476 | 1.8.3.4.1.1 | Test Approach |  | 20d? | 2025-01-07 | 2025-02-03 |  |  |  | 2025-01-07 | 2025-02-03 |  | 32259d | 0d | start no earlier than 2025-01-07 |  | SI Migration |  | Migration | 6.14 | Warren Fulton | Green | GREEN |  |  |  | 18.33 |
| 2477 | 1.8.3.4.1.2 | Test Plan |  | 20d? | 2025-02-04 | 2025-03-03 | 2476 |  |  | 2025-02-04 | 2025-03-03 |  | 32259d | 0d |  |  | SI Migration |  | Migration | 6.14 | Warren Fulton | Green | GREEN |  |  |  | 46.33 |
| 2478 | 1.8.3.4.1.3 | Other Framework items |  | 47d? | 2025-03-04 | 2025-05-07 | 2477 |  |  | 2025-03-04 | 2025-05-07 |  | 32259d |  |  |  | SI Migration |  | Migration | 6.14 | Warren Fulton | Green | GREEN |  |  |  | 74.33 |
| 2479 | 1.8.3.4.2 | Industry Consultation |  | 10d? | 2025-03-12 | 2025-03-25 |  |  |  | 2025-03-12 | 2025-03-25 |  | 32270d | 0d | start no earlier than 2025-03-12 |  | PP |  | Migration | 6.14 | Warren Fulton | Green | GREEN |  |  |  | 82.33 |
| 2480 | 1.8.3.4.3 | Triage Response |  | 10d? | 2025-03-26 | 2025-04-08 | 2479 |  |  | 2025-03-26 | 2025-04-08 |  | 32270d | 0d |  |  | SI Migration |  | Migration | 6.14 | Warren Fulton | Green | GREEN |  |  |  | 96.33 |
| 2481 | 1.8.3.4.4 | Assurance and MCAG Approval |  | 10d? | 2025-04-09 | 2025-04-22 | 2480 |  |  | 2025-04-09 | 2025-04-22 |  | 32270d | 0d |  |  | SI Migration |  | Migration | 6.14 | Warren Fulton | Green | GREEN |  |  |  | 110.33 |
| 2482 | 1.8.3.4.5 | Consultation 4 Approved | milestone | 0d | 2025-04-22 | 2025-04-22 | 2481 |  |  | 2025-04-22 | 2025-04-22 |  | 32270d | 0d |  |  | SI Migration |  | Migration | 6.14 | Warren Fulton | Green | GREEN |  |  |  | 123.71 |
| 2483 | 1.8.3.4.6 | Framework Baselined at MCAG | milestone | 0d | 2025-04-22 | 2025-04-22 | 2482 |  |  | 2025-04-22 | 2025-04-22 |  | 32270d |  |  |  | SI Migration |  | Migration | 6.14 | Warren Fulton | Green | GREEN | T3-MI-XXXX | MCAG (Migration) | T3 | 123.71 |

Notes:
- 2465: Guidance: 25/7/24: New Milestone approved at MCAG on 25/7/24
- 2473: Guidance: 25/7/24: Milestone name and date change approved at MCAG on 25/7/24. Date from 2/8/24 to 22/10/24. Name from 'Migration Processes & Procedures approved' to 'MCAG Approval of Migration Framework Artefacts (Baselined)’
- 2474: 11/12/24 - Dates for Consultation 4 included in the plan, these are due to be discussed and agreed at January MCAG.
- 2475: 11/12/24 - Dates for Consultation 4 included in the plan, these are due to be discussed and agreed at January MCAG.
- 2476: 11/12/24 - Dates for Consultation 4 included in the plan, these are due to be discussed and agreed at January MCAG.
- 2477: 11/12/24 - Dates for Consultation 4 included in the plan, these are due to be discussed and agreed at January MCAG.
- 2478: 11/12/24 - Dates for Consultation 4 included in the plan, these are due to be discussed and agreed at January MCAG.
- 2479: 11/12/24 - Dates for Consultation 4 included in the plan, these are due to be discussed and agreed at January MCAG.
- 2480: 11/12/24 - Dates for Consultation 4 included in the plan, these are due to be discussed and agreed at January MCAG.
- 2481: 11/12/24 - Dates for Consultation 4 included in the plan, these are due to be discussed and agreed at January MCAG.
- 2482: 11/12/24 - Dates for Consultation 4 included in the plan, these are due to be discussed and agreed at January MCAG.
- 2483: 11/12/24 - Dates for Consultation 4 included in the plan, these are due to be discussed and agreed at January MCAG.

| ID | WBS | Task | Type | Duration | Start | Finish | Predecessors | Complete | Remaining | Baseline start | Baseline finish | Baseline duration | Total slack | Free slack | Constraint | Baseline cost | Responsible | Involved | Text9 | Update Version | MHHS Resource Name | Sched Status | RAG | Task Status | Milestone ID | Text29 | Tier | Guidance |
| --- | --- | --- | --- | --- | --- | --- | --- | --- | --- | --- | --- | --- | --- | --- | --- | --- | --- | --- | --- | --- | --- | --- | --- | --- | --- | --- | --- | --- |
| 2484 | 1.8.4 | **Migration Schedule Agreed and Maintained** |  | 275d? | 2024-07-01 A | 2025-07-18 |  | 44% | 154.41d? | 2024-07-01 | 2026-01-30 | 207d | 32207d |  |  | -0 | SI Migration | N/A | Migration | 5.28 | Warren Fulton |  |  |  |  |  |  |  |
| 2485 | 1.8.4.1 | Indicative Envelopes Issued |  | 23d | 2024-07-01 A | 2024-07-31 A | 2458FS+37d | 100% |  | 2024-07-01 | 2024-07-31 | 23d |  |  |  |  | SRO Migration | SRO Migration,PP | Migration | 5.28 | Warren Fulton | Complete | COMPLETE |  |  |  |  |  |
| 2486 | 1.8.4.2 | Supplier Submissions |  | 45d | 2024-08-01 A | 2024-10-02 A | 2485, 2465 | 100% |  | 2024-08-01 | 2024-10-02 | 45d |  |  |  |  | PP | SRO Migration,PP | Migration | 5.28 | Warren Fulton | Complete | COMPLETE |  |  |  |  |  |
| 2487 | 1.8.4.3 | Team Assess Responses |  | 10d | 2024-10-03 A | 2024-10-16 A | 2486 | 100% |  | 2024-10-03 | 2024-10-16 | 10d |  |  |  |  | SRO Migration | SRO Migration | Migration | 5.28 | Warren Fulton | Complete | COMPLETE |  |  |  |  |  |
| 2488 | 1.8.4.4 | Discuss and Agree Approach with Participants where necessary |  | 4d | 2024-10-17 A | 2024-10-22 A | 2487 | 100% |  | 2024-10-17 | 2024-10-22 | 4d |  |  |  |  | SRO Migration | SRO Migration,PP | Migration | 5.28 | Warren Fulton | Complete | COMPLETE |  |  |  |  |  |
| 2489 | 1.8.4.5 | Schedule Production v1 |  | 25d? | 2024-11-18 | 2024-12-20 |  |  |  | 2024-11-18 | 2024-12-20 |  | 32357d |  | start no earlier than 2024-11-18 |  | SI Migration |  | Migration | 6.14 | Warren Fulton | Green | GREEN | -31.67 | T3-MI-XXXX | MCAG (Migration) | T3 |  |
| 2490 | 1.8.4.6 | Schedule Production v2 |  | 80d? | 2025-03-31 | 2025-07-18 |  |  |  | 2025-03-31 | 2025-07-18 |  | 31932d | 0d | start no earlier than 2025-03-31 |  | SI Migration |  | Migration | 6.14 | Warren Fulton | Green | GREEN | 101.33 | T3-MI-XXXX | MCAG (Migration) | T3 |  |
| 2491 | 1.8.4.7 | V1.0 of Migration Schedule Baseline Approved at MCAG | milestone | 0d | 2025-07-18 | 2025-07-18 | 2490 |  |  | 2025-07-18 | 2025-07-18 | 0d | 31932d | 0d |  |  | SI Migration | SRO Migration,PP | Migration | 6.14 | Warren Fulton | Green | GREEN | 210.71 | T3-MI-0039 | MCAG (Migration) | T3 | 25/7/24: New Milestone approved at MCAG on 25/7/24 |
| 2492 | 1.8.5 | **MCC Stood up** |  | 265d? | 2024-11-18 | 2025-11-21 |  |  |  | 2024-11-18 | 2025-11-21 |  |  |  |  |  | SI Migration |  | Migration | 6.14 | Warren Fulton | Overdue Start | RED | -771.67 |  |  |  |  |
| 2493 | 1.8.5.1 | **MPMT Delivered** |  | 265d? | 2024-11-18 | 2025-11-21 |  |  |  | 2024-11-18 | 2025-11-21 |  |  |  |  |  | SI Migration |  | Migration | 6.14 | Warren Fulton | Overdue Start | RED | -771.67 |  |  |  |  |
| 2494 | 1.8.5.1.1 | **Migration Planning Tool - Delivery** |  | 265d? | 2024-11-18 | 2025-11-21 |  |  |  | 2024-11-18 | 2025-11-21 |  |  |  |  |  | SI Migration |  | Migration | 6.14 | Warren Fulton | Overdue Start | RED | -771.67 |  |  |  |  |
| 2495 | 1.8.5.1.1.1 | MPMT Build Sprints - MVP |  | 120d? | 2025-01-06 | 2025-06-20 |  |  |  | 2025-01-06 | 2025-06-20 |  | 32227d |  | start no earlier than 2025-01-06 |  | SI Migration |  | Migration | 6.14 | Warren Fulton | Green | GREEN | 17.33 |  |  |  |  |
| 2496 | 1.8.5.1.1.2 | Delivery Activity |  | 265d? | 2024-11-18 | 2025-11-21 |  |  |  | 2024-11-18 | 2025-11-21 |  | 32117d |  |  |  | SI Migration |  | Migration | 6.14 | Warren Fulton | Green | GREEN | -31.67 |  |  |  |  |
| 2497 | 1.8.5.2 | MCC - Pilot | milestone | 0d | 2024-11-20 | 2024-11-20 |  |  |  | 2024-11-20 | 2024-11-20 |  | 32380d |  | start no earlier than 2024-11-20 |  | SI Migration |  | Migration | 6.14 | Warren Fulton | Green | GREEN | -29.67 |  |  |  |  |
| 2498 | 1.8.5.3 | MCC Stood up complete |  | 1d? | 2024-11-18 | 2024-11-18 |  |  |  | 2024-11-18 | 2024-11-18 |  | 32381d |  |  |  | SI Migration |  | Migration | 6.14 | Warren Fulton | Green | GREEN | -31.67 | T2-MI-XXXX | MCAG (Migration) | T2 |  |
| 2499 | 1.8.5.4 | Sprint Planning (Cycle 1) |  | 40d | 2025-12-22 | 2026-02-13 | 2491FS+110d |  |  | 2025-06-16 | 2025-08-08 | 20d | 31932d | 0d |  |  | SRO Migration | SRO Migration,PP | Migration | 5.28 | Warren Fulton | Red | RED | 367.33 |  |  |  |  |
| 2500 | 1.8.5.5 | Sprint Planning (Cycle 2) |  | 40d | 2026-03-23 | 2026-05-15 | 2499FS+25d |  |  | 2025-09-15 | 2025-11-07 | 20d | 31932d | 0d |  |  | SRO Migration | SRO Migration,PP | Migration | 5.28 | Warren Fulton | Red | RED | 458.33 |  |  |  |  |
| 2501 | 1.8.5.6 | Sprint Planning (Cycle 3) |  | 40d | 2026-06-15 | 2026-08-07 | 2500FS+20d, 2515 |  |  | 2025-12-08 | 2026-01-30 | 19d | 31932d |  |  |  | SRO Migration | SRO Migration,PP | Migration | 5.28 | Warren Fulton | Red | RED | 542.33 |  |  |  |  |
| 2502 | 1.8.6 | **Migration Control Centre Tooling** |  | 242d | 2024-05-09 A | 2025-04-11 |  | 66% | 81.56d | 2024-05-09 | 2025-04-11 | 182d | 32236d |  |  |  | N/A | N/A | Migration | 5.28 | Warren Fulton |  |  |  |  |  |  |  |
| 2503 | 1.8.6.1 | Data Source Definition |  | 120d | 2024-05-09 A | 2024-10-23 A | 2458 | 100% |  | 2024-05-09 | 2024-10-23 | 60d |  |  |  |  | SRO Migration | SRO Migration | Migration | 5.28 | Warren Fulton | Complete | COMPLETE |  |  |  |  |  |
| 2504 | 1.8.6.2 | Scheduling and Data Requirements |  | 120d | 2024-05-09 A | 2024-10-23 A | 2458 | 100% |  | 2024-05-09 | 2024-10-23 | 60d |  |  |  |  | SRO Migration | SRO Migration | Migration | 5.28 | Warren Fulton | Complete | COMPLETE |  |  |  |  |  |
| 2505 | 1.8.6.3 | Tool Phase 1 |  | 11d | 2024-10-24 | 2024-11-07 | 2504, 2503 |  |  | 2024-10-24 | 2024-11-07 | 11d | 32236d | 0d |  |  | SRO Migration | SRO Migration | Migration | 5.28 | Warren Fulton | Green | RED | -56.67 |  |  |  |  |
| 2506 | 1.8.6.4 | Data Requirements |  | 21d | 2024-11-08 | 2024-12-06 | 2458, 2505 |  |  | 2024-11-08 | 2024-12-06 | 21d | 32236d | 0d |  |  | SRO Migration | SRO Migration | Migration | 5.28 | Warren Fulton | Green | GREEN | -41.67 |  |  |  |  |
| 2507 | 1.8.6.5 | Tool Phase 2 |  | 25d | 2024-12-09 | 2025-01-10 | 2506 |  |  | 2024-12-09 | 2025-01-10 | 25d | 32236d | 0d |  |  | SRO Migration | SRO Migration | Migration | 5.28 | Warren Fulton | Green | GREEN | -10.67 |  |  |  |  |
| 2508 | 1.8.6.6 | Data Source Provision |  | 7d | 2025-01-13 | 2025-01-21 | 2507 |  |  | 2025-01-13 | 2025-01-21 | 7d | 32236d | 0d |  |  | SRO Migration | SRO Migration | Migration | 5.28 | Warren Fulton | Green | GREEN | 24.33 |  |  |  |  |
| 2509 | 1.8.6.7 | Tool - Internal and External Testing |  | 58d | 2025-01-22 | 2025-04-11 | 2508 |  |  | 2025-01-22 | 2025-04-11 | 58d | 32236d | 14d |  |  | SRO Migration | SRO Migration,PP | Migration | 5.28 | Warren Fulton | Green | GREEN | 33.33 |  |  |  |  |

Notes:
- 2491: 11/12/24 - The Programme is updating the Migration Schedule, with a discussion due at MCAG in January to agree this. Proposed that this milestone date is updated, but not baselined yet.
- 2492: 11/12/24 - The Programme is currently creating the MCC stand up plan, these activities will be updated over the coming weeks as further detail is agreed with MCAG.
- 2493: 11/12/24 - The Programme is currently creating the MCC stand up plan, these activities will be updated over the coming weeks as further detail is agreed with MCAG.
- 2494: 11/12/24 - The Programme is currently creating the MCC stand up plan, these activities will be updated over the coming weeks as further detail is agreed with MCAG.
- 2495: 11/12/24 - The Programme is currently creating the MCC stand up plan, these activities will be updated over the coming weeks as further detail is agreed with MCAG.
- 2496: 11/12/24 - The Programme is currently creating the MCC stand up plan, these activities will be updated over the coming weeks as further detail is agreed with MCAG.
- 2497: 11/12/24 - The Programme is currently creating the MCC stand up plan, these activities will be updated over the coming weeks as further detail is agreed with MCAG.
- 2498: 11/12/24 - The Programme is currently creating the MCC stand up plan, these activities will be updated over the coming weeks as further detail is agreed with MCAG.
- 2499: 11/12/24 - The Programme proposes to remove this activity and replace them with the 'MCC Stood up' activity. This is due to be discussed at January hence why it's still in the plan and only struck-through.
- 2500: 11/12/24 - The Programme proposes to remove this activity and replace them with the 'MCC Stood up' activity. This is due to be discussed at January hence why it's still in the plan and only struck-through.
- 2501: 11/12/24 - The Programme proposes to remove this activity and replace them with the 'MCC Stood up' activity. This is due to be discussed at January hence why it's still in the plan and only struck-through. / Action: 8/7/24: Successor was on M10 (1861 id903) - I removed as it was moving the date out
- 2502: 11/12/24 - The Programme proposes to remove this activity and replace them with the 'MCC Stood up' activity. This is due to be discussed at January hence why it's still in the plan and only struck-through.
- 2503: 11/12/24 - The Programme proposes to remove this activity and replace them with the 'MCC Stood up' activity. This is due to be discussed at January hence why it's still in the plan and only struck-through.
- 2504: 11/12/24 - The Programme proposes to remove this activity and replace them with the 'MCC Stood up' activity. This is due to be discussed at January hence why it's still in the plan and only struck-through.
- 2505: 11/12/24 - The Programme proposes to remove this activity and replace them with the 'MCC Stood up' activity. This is due to be discussed at January hence why it's still in the plan and only struck-through. / Action: 9/7/24: To be expanded once clarified
- 2506: 11/12/24 - The Programme proposes to remove this activity and replace them with the 'MCC Stood up' activity. This is due to be discussed at January hence why it's still in the plan and only struck-through. / Action: 9/7/24: To be expanded once clarified
- 2507: 11/12/24 - The Programme proposes to remove this activity and replace them with the 'MCC Stood up' activity. This is due to be discussed at January hence why it's still in the plan and only struck-through. / Action: 9/7/24: To be expanded once clarified
- 2508: 11/12/24 - The Programme proposes to remove this activity and replace them with the 'MCC Stood up' activity. This is due to be discussed at January hence why it's still in the plan and only struck-through. / Action: 9/7/24: To be expanded once clarified
- 2509: 11/12/24 - The Programme proposes to remove this activity and replace them with the 'MCC Stood up' activity. This is due to be discussed at January hence why it's still in the plan and only struck-through. / Action: 9/7/24: To be expanded once clarified

| ID | WBS | Task | Type | Duration | Start | Finish | Predecessors | Complete | Remaining | Baseline start | Baseline finish | Baseline duration | Baseline 1 start | Baseline 1 finish | Total slack | Free slack | Baseline cost | Responsible | Involved | Text9 | Update Version | MHHS Resource Name | Sched Status | RAG | Task Status | MHHS Programme Phase | Artefact ID | Milestone ID | Text29 | Tier |
| --- | --- | --- | --- | --- | --- | --- | --- | --- | --- | --- | --- | --- | --- | --- | --- | --- | --- | --- | --- | --- | --- | --- | --- | --- | --- | --- | --- | --- | --- | --- |
| 2510 | 1.8.7 | **Migration Control Centre Mobilised and Ready** |  | 199d | 2024-07-30 A | 2025-05-02 |  | 1% | 196.63d | 2024-07-30 | 2025-04-14 | 134d |  |  | 32222d |  |  | N/A | N/A | Migration | 5.28 | Warren Fulton |  |  |  |  |  |  |  |  |
| 2511 | 1.8.7.1 | Migration Control Centre TOM Definition |  | 65d | 2024-07-30 A | 2024-10-28 | 2465FS+2d | 3% | 63d | 2024-07-30 | 2024-10-28 | 29d |  |  | 32250d | 0d |  | SRO Migration | SRO Migration | Migration | 5.28 | Warren Fulton | Green | GREEN |  |  |  |  |  |  |
| 2512 | 1.8.7.2 | Access to Data |  | 25d | 2024-11-04 | 2024-12-06 | 2511FS+4d |  |  | 2024-11-04 | 2024-12-06 | 25d |  |  | 32250d | 0d |  | SRO Migration | SRO Migration | Migration | 5.28 | Warren Fulton | Green | GREEN | -45.67 |  |  |  |  |  |
| 2513 | 1.8.7.3 | Migration Control Centre Delegation of Authority |  | 12d | 2024-12-24 | 2025-01-08 | 2512FS+11d |  |  | 2024-12-24 | 2025-01-08 | 12d |  |  | 32250d | 0d |  | SRO Migration | SRO Migration | Migration | 5.28 | Warren Fulton | Green | GREEN | 4.33 |  |  |  |  |  |
| 2514 | 1.8.7.4 | Recruit and Train |  | 65d | 2024-12-24 | 2025-03-24 | 2513SS |  |  | 2024-12-24 | 2025-03-24 | 65d |  |  | 32250d | 28d |  | SRO Migration | SRO Migration | Migration | 5.28 | Warren Fulton | Green | GREEN | 4.33 |  |  |  |  |  |
| 2515 | 1.8.7.5 | Dress Rehearsal |  | 1d | 2025-05-02 | 2025-05-02 | 2509, 2514, 2519, 2520 |  |  | 2025-04-14 | 2025-04-14 | 1d |  |  | 32222d | 290d |  | SRO Migration | SRO Migration | Migration | 5.28 | Warren Fulton | Red | RED | 133.33 |  |  |  |  |  |
| 2516 | 1.8.8 | **PP's Prepared for Migration** |  | 219d | 2024-07-01 A | 2025-05-01 |  | 23% | 168.46d | 2024-07-01 | 2025-03-31 | 154d |  |  | 32222d |  | -0 | N/A | N/A | Migration | 5.28 | Warren Fulton |  |  |  |  |  |  |  |  |
| 2517 | 1.8.8.1 | Prep for Envelope Webinar |  | 26d | 2024-07-01 A | 2024-08-05 A | 2485SS | 100% |  | 2024-07-01 | 2024-08-05 | 26d |  |  |  |  |  | SRO Migration | SRO Migration | Migration | 5.28 | Warren Fulton | Complete | COMPLETE |  |  |  |  |  |  |
| 2518 | 1.8.8.2 | Envelope/Submission Webinar |  | 1d | 2024-08-05 A | 2024-08-05 A | 2517FF | 100% |  | 2024-08-05 | 2024-08-05 | 1d |  |  |  |  |  | SRO Migration | SRO Migration,PP | Migration | 5.28 | Warren Fulton | Complete | COMPLETE |  |  |  |  |  |  |
| 2519 | 1.8.8.3 | Guides Creation |  | 45d | 2025-02-28 | 2025-05-01 | 2473FS+2d |  |  | 2025-01-28 | 2025-03-31 | 45d |  |  | 32222d | 0d |  | SRO Migration | SRO Migration,PP | Migration | 5.28 | Warren Fulton | Red | RED | 70.33 |  |  |  |  |  |
| 2520 | 1.8.8.4 | Support Channels |  | 45d | 2025-02-28 | 2025-05-01 | 2473FS+2d |  |  | 2025-01-28 | 2025-03-31 | 45d |  |  | 32222d | 0d |  | SRO Migration | SRO Migration,PP | Migration | 5.28 | Warren Fulton | Red | RED | 70.33 |  |  |  |  |  |
| 2521 | 1.8.9 | **Migration Artefact Development and Publication** |  | 773d | 2022-10-31 A | 2025-10-15 |  | 88% | 89.36d | 2022-10-31 | 2025-09-03 | 635d | 2022-10-31 | 2025-04-04 | 32144d |  | -0 | N/A | N/A | Migration | 5.0 | Warren Fulton |  |  |  | Migration |  |  |  |  |
| 2522 | 1.8.9.1 | **Migration Approach** |  | 28d | 2022-10-31 A | 2022-12-07 A |  | 100% |  | 2022-10-31 | 2022-12-07 | 28d | 2022-10-31 | 2022-12-07 |  |  |  | N/A | N/A | Migration | 5.0 | Warren Fulton |  |  |  | Migration |  |  |  |  |
| 2523 | 1.8.9.1.1 | Option analysis (via MWG and PPIR) and recommendation |  | 23d | 2022-10-31 A | 2022-11-30 A |  | 100% |  | 2022-10-31 | 2022-11-30 | 23d | 2022-10-31 | 2022-11-30 |  |  |  | PP | SI Migration | Migration | 5.0 | John Wiggins,Matthew Breen | Complete | COMPLETE |  | Migration |  |  |  |  |
| 2524 | 1.8.9.1.2 | Migration Approach approved | milestone | 0d | 2022-12-07 A | 2022-12-07 A | 2523FS+5d | 100% |  | 2022-12-07 | 2022-12-07 | 0d | 2022-12-07 | 2022-12-07 |  |  |  | SI Migration | PP,IPA | Migration | 5.0 | John Wiggins,Matthew Breen | Complete | COMPLETE |  | Migration | MHHS-DEL770 | T3-MI-0010 | PSG | T3 |
| 2525 | 1.8.9.2 | **Migration Design** |  | 100d | 2022-11-14 A | 2023-03-31 A |  | 100% |  | 2022-11-14 | 2023-03-31 | 100d | 2022-11-14 | 2023-03-31 |  |  |  | N/A | N/A | Migration | 5.0 | N/A |  |  |  | Migration |  |  |  |  |
| 2526 | 1.8.9.2.1 | Review and update existing design artefacts and socialise with participants ahead of MDSG |  | 10d | 2022-11-14 A | 2022-11-25 A |  | 100% |  | 2022-11-14 | 2022-11-25 | 10d | 2022-11-14 | 2022-11-25 |  |  |  | SI Migration | SRO Design,CPT | Migration | 5.0 | John Wiggins,Matthew Breen | Complete | COMPLETE |  | Migration |  |  |  |  |
| 2527 | 1.8.9.2.2 | Develop design artefacts and supporting technical documents in line with MDSG |  | 53d | 2022-11-30 A | 2023-02-10 A | 2526FS+2d | 100% |  | 2022-11-30 | 2023-02-10 | 53d | 2022-11-30 | 2023-02-10 |  |  |  | SI Migration | PP,SRO Function,CPT | Migration | 5.0 | John Wiggins,Matthew Breen | Complete | COMPLETE |  | Migration |  |  |  |  |
| 2528 | 1.8.9.2.3 | Migration design artefacts issued for consultation | milestone | 0d | 2023-02-13 A | 2023-02-13 A | 2527FS+1d | 100% |  | 2023-02-13 | 2023-02-13 | 0d | 2023-02-13 | 2023-02-13 |  |  |  | SI Migration | PP,SRO Function,CPT | Migration | 5.0 | John Wiggins,Matthew Breen | Complete | COMPLETE |  | Migration |  | T3-MI-0011 | DAG | T3 |
| 2529 | 1.8.9.2.4 | Industry consultation |  | 5d | 2023-02-14 A | 2023-02-20 A | 2528SS | 100% |  | 2023-02-14 | 2023-02-20 | 5d | 2023-02-14 | 2023-02-20 |  |  |  | PP | SI Migration | Migration | 5.0 | John Wiggins,Matthew Breen | Complete | COMPLETE |  | Migration |  |  |  |  |
| 2530 | 1.8.9.2.5 | Review consultation feedback, address comments and update artefacts |  | 5d | 2023-02-21 A | 2023-02-27 A | 2529 | 100% |  | 2023-02-21 | 2023-02-27 | 5d | 2023-02-21 | 2023-02-27 |  |  |  | SI Migration | PP | Migration | 5.0 | John Wiggins,Matthew Breen | Complete | COMPLETE |  | Migration |  |  |  |  |
| 2531 | 1.8.9.2.6 | Internal artefact review and comms preparation |  | 3d | 2023-02-28 A | 2023-03-02 A | 2530 | 100% |  | 2023-02-28 | 2023-03-02 | 3d | 2023-02-28 | 2023-03-02 |  |  |  | SI Migration | SRO Function | Migration | 5.0 | John Wiggins,Matthew Breen | Complete | COMPLETE |  | Migration |  |  |  |  |
| 2532 | 1.8.9.2.7 | Updated Migration Design artefacts issued to PPs for assurance review | milestone | 0d | 2023-03-03 A | 2023-03-03 A | 2531FS+1d | 100% |  | 2023-03-03 | 2023-03-03 | 0d | 2023-03-03 | 2023-03-03 |  |  |  | SI Migration | PP | Migration | 5.0 | John Wiggins,Matthew Breen | Complete | COMPLETE |  | Migration |  | T3-MI-0013 | DAG | T3 |
| 2533 | 1.8.9.2.8 | Final Migration Design artefacts walkthrough with PPs | milestone | 0d | 2023-03-22 A | 2023-03-22 A | 2532FS+13d | 100% |  | 2023-03-22 | 2023-03-22 | 0d | 2023-03-22 | 2023-03-22 |  |  |  | SI Migration | PP | Migration | 5.0 | John Wiggins,Matthew Breen | Complete | COMPLETE |  | Migration |  |  |  |  |
| 2534 | 1.8.9.2.9 | Migration Design approved | milestone | 0d | 2023-03-31 A | 2023-03-31 A | 2533FS+7d | 100% |  | 2023-03-31 | 2023-03-31 | 0d | 2023-03-31 | 2023-03-31 |  |  |  | SI Migration | PP,SRO Function,CPT | Migration | 5.0 | John Wiggins,Matthew Breen | Complete | COMPLETE |  | Migration |  | T2-MI-0050 | DAG | T2 |

Notes:
- 2510: 11/12/24 - The Programme proposes to remove this activity and replace them with the 'MCC Stood up' activity. This is due to be discussed at January hence why it's still in the plan and only struck-through.
- 2511: 11/12/24 - The Programme proposes to remove this activity and replace them with the 'MCC Stood up' activity. This is due to be discussed at January hence why it's still in the plan and only struck-through.
- 2512: 11/12/24 - The Programme proposes to remove this activity and replace them with the 'MCC Stood up' activity. This is due to be discussed at January hence why it's still in the plan and only struck-through.
- 2513: 11/12/24 - The Programme proposes to remove this activity and replace them with the 'MCC Stood up' activity. This is due to be discussed at January hence why it's still in the plan and only struck-through.
- 2514: 11/12/24 - The Programme proposes to remove this activity and replace them with the 'MCC Stood up' activity. This is due to be discussed at January hence why it's still in the plan and only struck-through.
- 2515: 11/12/24 - The Programme proposes to remove this activity and replace them with the 'MCC Stood up' activity. This is due to be discussed at January hence why it's still in the plan and only struck-through.

| ID | WBS | Task | Type | Duration | Start | Finish | Predecessors | Complete | Baseline start | Baseline finish | Baseline duration | Baseline 1 start | Baseline 1 finish | Baseline cost | Responsible | Involved | Text9 | Update Version | MHHS Resource Name | MHHS Programme Phase | Sched Status | RAG | Milestone ID | Text29 | Tier | Guidance |
| --- | --- | --- | --- | --- | --- | --- | --- | --- | --- | --- | --- | --- | --- | --- | --- | --- | --- | --- | --- | --- | --- | --- | --- | --- | --- | --- |
| 2535 | 1.8.9.3 | **Transition Design** |  | 186d | 2023-03-01 A | 2023-11-15 A |  | 100% | 2023-03-01 | 2023-11-15 | 186d | 2023-03-01 | 2023-08-03 | -0 | N/A | N/A | Migration | 5.0 | N/A | Migration |  |  |  |  |  |  |
| 2536 | 1.8.9.3.1 | **Tranche 1** |  | 56d | 2023-03-01 A | 2023-05-17 A |  | 100% | 2023-03-01 | 2023-05-17 | 56d | 2023-03-01 | 2023-05-17 |  | N/A | N/A | Migration | 5.0 | N/A | Migration |  |  |  |  |  |  |
| 2537 | 1.8.9.3.1.1 | Develop design artefacts and supporting technical details with participants |  | 50d | 2023-03-01 A | 2023-05-09 A |  | 100% | 2023-03-01 | 2023-05-09 | 50d | 2023-03-01 | 2023-05-09 |  | SI Design | PP | Migration | 5.0 | Andrew Margan | Migration | Complete | COMPLETE |  |  |  |  |
| 2538 | 1.8.9.3.1.2 | Issue Material for DAG approval |  | 1d | 2023-05-10 A | 2023-05-10 A | 2537 | 100% | 2023-05-10 | 2023-05-10 | 1d | 2023-05-10 | 2023-05-10 |  | PP | SI Design | Migration | 5.0 | Andrew Margan | Migration | Complete | COMPLETE |  |  |  |  |
| 2539 | 1.8.9.3.1.3 | Tranche 1 Transition Design approved | milestone | 0d | 2023-05-17 A | 2023-05-17 A | 2538FS+5d | 100% | 2023-05-17 | 2023-05-17 | 0d | 2023-05-17 | 2023-05-17 |  | SI Design | PP | Migration | 5.0 | Andrew Margan | Migration | Complete | COMPLETE | T2-DB-0150 | DAG | T2 |  |
| 2540 | 1.8.9.3.2 | **Tranche 2** |  | 130d | 2023-05-18 A | 2023-11-15 A |  | 100% | 2023-05-18 | 2023-11-15 | 130d | 2023-05-18 | 2023-08-03 | -0 | N/A | N/A | Migration | 5.0 | N/A | Migration |  |  |  |  |  |  |
| 2541 | 1.8.9.3.2.1 | Develop Initial design artefacts and supporting technical details |  | 76d | 2023-05-18 A | 2023-08-31 A | 2539 | 100% | 2023-05-18 | 2023-08-31 | 76d | 2023-05-18 | 2023-07-26 |  | SRO | PP, CPT, SRO Design | Migration | 5.5 | Andrew Margan | Migration | Complete | COMPLETE |  |  |  |  |
| 2542 | 1.8.9.3.2.2 | Communicate Initial Design Artefacts with Industry (MTDSG) |  | 1d | 2023-09-01 A | 2023-09-01 A | 2541 | 100% | 2023-09-01 | 2023-09-01 | 1d |  |  |  | SRO | PP, CPT, SRO Design | Migration | 5.5 | Andrew Margan | Migration | Complete | COMPLETE |  |  |  |  |
| 2543 | 1.8.9.3.2.3 | Host MTDSG |  | 1d | 2023-09-11 A | 2023-09-11 A | 2542FS+5d | 100% | 2023-09-11 | 2023-09-11 | 1d |  |  |  | SRO | PP, CPT, SRO Design | Migration | 5.5 | Andrew Margan | Migration | Complete | COMPLETE |  |  |  |  |
| 2544 | 1.8.9.3.2.4 | Process MTDSG Feedback and Amend Design Artefacts |  | 4d | 2023-09-12 A | 2023-09-15 A | 2543 | 100% | 2023-09-12 | 2023-09-15 | 4d |  |  |  | SRO | PP, CPT, SRO Design | Migration | 5.5 | Andrew Margan | Migration | Complete | COMPLETE |  |  |  |  |
| 2545 | 1.8.9.3.2.5 | Communicate Amended Design Artefacts with Industry |  | 1d | 2023-09-15 A | 2023-09-15 A | 2544FF | 100% | 2023-09-15 | 2023-09-15 | 1d |  |  |  | SRO | PP, CPT, SRO Design | Migration | 5.5 | Andrew Margan | Migration | Complete | COMPLETE |  |  |  |  |
| 2546 | 1.8.9.3.2.6 | Host MTDSG |  | 1d | 2023-09-26 A | 2023-09-26 A | 2545FS+6d | 100% | 2023-09-26 | 2023-09-26 | 1d |  |  |  | SRO | PP, CPT, SRO Design | Migration | 5.5 | Andrew Margan | Migration | Complete | COMPLETE |  |  |  |  |
| 2547 | 1.8.9.3.2.7 | Make Final Amendments to Design Artefact |  | 5d | 2023-09-27 A | 2023-10-03 A | 2546 | 100% | 2023-09-27 | 2023-10-03 | 5d |  |  |  | SRO | PP, CPT, SRO Design | Migration | 5.5 | Andrew Margan | Migration | Complete | COMPLETE |  |  |  |  |
| 2548 | 1.8.9.3.2.8 | Request DAG Consultation |  | 1d | 2023-10-04 A | 2023-10-04 A | 2547 | 100% | 2023-10-04 | 2023-10-04 | 1d |  |  |  | SRO | PP, CPT, SRO Design | Migration | 5.5 | Andrew Margan | Migration | Complete | COMPLETE |  |  |  |  |
| 2549 | 1.8.9.3.2.9 | Consultation Period |  | 11d | 2023-10-04 A | 2023-10-18 A | 2548SS | 100% | 2023-10-04 | 2023-10-18 | 11d |  |  |  | SRO | PP, CPT, SRO Design | Migration | 5.5 | Andrew Margan | Migration | Complete | COMPLETE |  |  |  |  |
| 2550 | 1.8.9.3.2.10 | Action Consultation Comments |  | 5d | 2023-10-19 A | 2023-10-25 A | 2549 | 100% | 2023-10-19 | 2023-10-25 | 5d |  |  |  | SRO | PP, CPT, SRO Design | Migration | 5.5 | Andrew Margan | Migration | Complete | COMPLETE |  |  |  |  |
| 2551 | 1.8.9.3.2.11 | Post Consultation Industry Assurance |  | 5d | 2023-10-26 A | 2023-11-01 A | 2550 | 100% | 2023-10-26 | 2023-11-01 | 5d |  |  |  | SRO | PP, CPT, SRO Design | Migration | 5.5 | Andrew Margan | Migration | Complete | COMPLETE |  |  |  |  |
| 2552 | 1.8.9.3.2.12 | Request DAG Approval |  | 1d | 2023-11-01 A | 2023-11-01 A | 2551FF | 100% | 2023-11-01 | 2023-11-01 | 1d |  |  |  | SRO | PP, CPT, SRO Design | Migration | 5.5 | Andrew Margan | Migration | Complete | COMPLETE |  |  |  |  |
| 2553 | 1.8.9.3.2.13 | DAG Transition Design Approved |  | 1d | 2023-11-08 A | 2023-11-08 A | 2552FS+4d | 100% | 2023-11-08 | 2023-11-08 | 1d |  |  |  | SRO | PP, CPT, SRO Design | Migration | 5.5 | Andrew Margan | Migration | Complete | COMPLETE |  |  |  |  |
| 2554 | 1.8.9.3.2.14 | Update Transition Design Admin |  | 5d | 2023-11-09 A | 2023-11-15 A | 2553 | 100% | 2023-11-09 | 2023-11-15 | 5d |  |  |  | SRO | PP, CPT, SRO Design | Migration | 5.5 | Andrew Margan | Migration | Complete | COMPLETE |  |  |  |  |
| 2555 | 1.8.9.3.2.15 | Tranche 2 Transition Design Baselined | milestone | 0d | 2023-11-15 A | 2023-11-15 A | 2554 | 100% | 2023-11-15 | 2023-11-15 | 0d | 2023-08-03 | 2023-08-03 |  | SRO | PP, CPT, SRO Design | Migration | 5.12 | Andrew Margan | Migration | Complete | COMPLETE | T2-DB-0250 | DAG | T2 | 14/8 - Date aligns with DAG |
| 2556 | 1.8.9.4 | **Data Assessment Report** |  | 61d | 2022-12-06 A | 2023-02-28 A |  | 100% | 2022-12-06 | 2023-02-28 | 61d | 2022-12-06 | 2023-02-28 |  | N/A | N/A | Migration | 5.0 | N/A | Migration |  |  |  |  |  |  |
| 2557 | 1.8.9.4.1 | Develop document with MWG |  | 49d | 2022-12-06 A | 2023-02-10 A |  | 100% | 2022-12-06 | 2023-02-10 | 49d | 2022-12-06 | 2023-02-10 |  | SI Migration |  | Migration | 5.0 | John Wiggins,Matthew Breen | Migration | Complete | COMPLETE |  |  |  |  |
| 2558 | 1.8.9.4.2 | Artefact review (via TMAG) and updates |  | 25d | 2023-01-18 A | 2023-02-21 A | 2557FS-18d | 100% | 2023-01-18 | 2023-02-21 | 25d | 2023-01-18 | 2023-02-21 |  | PP | IPA,SI Migration | Migration | 5.0 | John Wiggins,Matthew Breen | Migration | Complete | COMPLETE |  |  |  |  |
| 2559 | 1.8.9.4.3 | Data Assessment Report approved | milestone | 0d | 2023-02-28 A | 2023-02-28 A | 2558FS+5d | 100% | 2023-02-28 | 2023-02-28 | 0d | 2023-02-28 | 2023-02-28 |  | SI Migration | PP,IPA | Migration | 5.0 | John Wiggins,Matthew Breen | Migration | Complete | COMPLETE | T3-MI-0012 | MCAG | T3 |  |

Notes:
- 2555: Action: 2/8/23 - needs to be replanned to 15//11/23. AM to raise CR as T2 milestone

| ID | WBS | Task | Type | Duration | Start | Finish | Predecessors | Complete | Remaining | Baseline start | Baseline finish | Baseline duration | Baseline 1 start | Baseline 1 finish | Total slack | Free slack | Constraint | Baseline cost | Responsible | Involved | Text9 | Update Version | MHHS Resource Name | MHHS Programme Phase | Sched Status | RAG | Milestone ID | Text29 | Tier | Task Status | Guidance |
| --- | --- | --- | --- | --- | --- | --- | --- | --- | --- | --- | --- | --- | --- | --- | --- | --- | --- | --- | --- | --- | --- | --- | --- | --- | --- | --- | --- | --- | --- | --- | --- |
| 2560 | 1.8.9.5 | **Migration, Cutover & Data Strategy (incl. Migration Entry Criteria)** |  | 102d | 2022-12-08 A | 2023-04-28 A |  | 100% |  | 2022-12-08 | 2023-04-28 | 102d | 2022-12-08 | 2023-04-28 |  |  |  |  | N/A | N/A | Migration | 5.0 | N/A | Migration |  |  |  |  |  |  |  |
| 2561 | 1.8.9.5.1 | Develop document with MWG |  | 67d | 2022-12-08 A | 2023-03-10 A | 2524 | 100% |  | 2022-12-08 | 2023-03-10 | 67d | 2022-12-08 | 2023-03-10 |  |  |  |  | SI Migration | PP | Migration | 5.0 | John Wiggins,Matthew Breen | Migration | Complete | COMPLETE |  |  |  |  |  |
| 2562 | 1.8.9.5.2 | Artefact review (via TMAG) and updates |  | 28d | 2023-03-15 A | 2023-04-21 A | 2561FS+2d | 100% |  | 2023-03-15 | 2023-04-21 | 28d | 2023-03-15 | 2023-04-21 |  |  |  |  | PP | SI Migration | Migration | 5.0 | John Wiggins,Matthew Breen | Migration | Complete | COMPLETE |  |  |  |  |  |
| 2563 | 1.8.9.5.3 | Migration, Cutover & Data Strategy approved | milestone | 0d | 2023-04-28 A | 2023-04-28 A | 2562FF+5d | 100% |  | 2023-04-28 | 2023-04-28 | 0d | 2023-04-28 | 2023-04-28 |  |  |  |  | SI Migration | PP | Migration | 5.0 | John Wiggins,Matthew Breen | Migration | Complete | COMPLETE | T3-MI-0014 | MCAG | T3 |  |  |
| 2564 | 1.8.9.6 | **Data Cleanse Plan** |  | 685d | 2023-03-02 A | 2025-10-15 |  | 80% | 136.77d | 2023-03-02 | 2025-09-03 | 547d | 2023-03-02 | 2025-04-04 | 32144d |  |  | -0 | N/A | N/A | Migration | 5.0 | N/A | Migration |  |  |  |  |  |  |  |
| 2565 | 1.8.9.6.1 | Develop document with MWG |  | 50d | 2023-03-02 A | 2023-05-10 A |  | 100% |  | 2023-03-02 | 2023-05-10 | 50d | 2023-03-02 | 2023-05-10 |  |  |  |  | SI Migration | PP | Migration | 5.0 | John Wiggins,Matthew Breen | Migration | Complete | COMPLETE |  |  |  |  |  |
| 2566 | 1.8.9.6.2 | Artefact review (via TMAG) and updates |  | 20d | 2023-05-11 A | 2023-06-07 A | 2565 | 100% |  | 2023-05-11 | 2023-06-07 | 20d | 2023-05-11 | 2023-06-07 |  |  |  |  | PP | SI Migration,IPA | Migration | 5.0 | John Wiggins,Matthew Breen | Migration | Complete | COMPLETE |  |  |  |  |  |
| 2567 | 1.8.9.6.3 | Data Cleanse Plan approved | milestone | 0d | 2023-07-19 A | 2023-07-19 A | 2566FS+30d | 100% |  | 2023-07-19 | 2023-07-19 | 0d | 2023-06-14 | 2023-06-14 |  |  |  |  | SI Migration | PP | Migration | 5.0 | John Wiggins,Matthew Breen | Migration | Complete | COMPLETE | T3-MI-0020 | MCAG | T3 |  |  |
| 2568 | 1.8.9.6.4 | Monitor Programme Participant adherence to Data Cleanse Plan |  | 467d | 2023-06-15 A | 2025-03-28 | 2567 | 76% | 114d | 2023-06-15 | 2025-03-28 | 467d | 2023-06-15 | 2025-03-28 | 32287d |  |  |  | SI Migration | PP | Migration | 5.0 | Matthew Breen | Migration | Green | GREEN |  |  |  |  |  |
| 2569 | 1.8.9.6.5 | **MTDs** |  | 115d | 2024-08-16 A | 2025-01-24 |  | 95% | 5.75d | 2024-08-16 | 2025-01-31 | 91d |  |  | 32332d |  |  | -0 | N/A | N/A | Transition | 5.4 | N/A | Migration |  |  |  |  |  |  |  |
| 2570 | 1.8.9.6.5.1 | **ESME ID** |  | 90d | 2024-08-16 A | 2024-12-20 |  | 94% | 5.29d | 2024-08-16 | 2024-12-20 | 90d |  |  | 32357d |  |  | -0 | N/A | N/A | Transition | 5.4 | N/A | Migration |  |  |  |  |  |  |  |
| 2571 | 1.8.9.6.5.1.1 | DCC to extract ESME ID and share with LDSO | milestone | 0d | 2024-08-16 A | 2024-08-16 A | 2567FS+282d | 100% |  | 2024-08-16 | 2024-08-16 | 0d |  |  |  |  |  |  | DCC/SI |  | Transition | 5.5 | Matthew Breen | Migration | Complete | COMPLETE | T3-MI-0024 | MCAG (Transition) | T3 |  |  |
| 2572 | 1.8.9.6.5.1.2 | LDSO ‘full refresh’ between their Registration Service and the EES (ESME ID) |  | 16d | 2024-10-21 A | 2024-11-11 A | 2571FS+45d | 100% |  | 2024-10-21 | 2024-11-11 | 0d |  |  |  |  |  |  | LDSO/EES |  | Transition | 5.5 | Matthew Breen | Migration | Complete | COMPLETE | T3-MI-0025 | MCAG (Transition) | T3 |  |  |
| 2573 | 1.8.9.6.5.1.3 | Suppliers complete investigation of exceptions and resolution of exceptions |  | 1d | 2024-12-20 | 2024-12-20 | 2572FS+28d |  |  | 2024-12-20 | 2024-12-20 | 1d |  |  | 32357d | 0d |  |  | Supplier |  | Transition | 5.4 | Matthew Breen | Migration | Green | GREEN |  |  |  | 0.33 |  |
| 2574 | 1.8.9.6.5.1.4 | ESME ID Complete | milestone | 0d | 2024-12-20 | 2024-12-20 | 2573 |  |  | 2024-12-20 | 2024-12-20 | 0d |  |  | 32357d |  |  |  |  |  | Transition | 5.4 | Matthew Breen | Migration | Green | GREEN |  |  |  | 0.71 |  |
| 2575 | 1.8.9.6.5.2 | **Meter Location and Number of Displayed Register Digits** |  | 96d | 2024-09-13 A | 2025-01-24 |  | 96% | 4.17d | 2024-09-13 | 2025-01-31 | 91d |  |  | 32332d |  |  |  | N/A | N/A | Transition | 5.4 | N/A | Migration |  |  |  |  |  |  |  |
| 2576 | 1.8.9.6.5.2.1 | MEM to extract data and share with LDSO |  | 6d | 2024-09-13 A | 2024-09-20 A | 2567FS+301d | 100% |  | 2024-09-13 | 2024-09-20 | 1d |  |  |  |  |  |  | MEM/SI |  | Transition | 5.4 | Matthew Breen | Migration | Complete | COMPLETE |  |  |  |  |  |
| 2577 | 1.8.9.6.5.2.2 | LDSO ‘full refresh’ between their Registration Service and the EES (Meter Location and Number of Displayed Register Digits) |  | 16d | 2024-10-21 A | 2024-11-15 A | 2576FS+25d | 100% |  | 2024-10-28 | 2024-11-18 | 0d |  |  |  |  |  |  | LDSO /EES |  | Transition | 5.5 | Matthew Breen | Migration | Complete | COMPLETE | T3-MI-0026 | MCAG (Transition) | T3 |  |  |
| 2578 | 1.8.9.6.5.2.3 | Suppliers complete investigation of exceptions and resolution of exceptions |  | 1d | 2025-01-24 | 2025-01-24 | 2577FS+49d |  |  | 2025-01-31 | 2025-01-31 | 1d |  |  | 32332d | 0d |  |  | Supplier |  | Transition | 5.4 | Matthew Breen | Migration | Green | GREEN |  |  |  | 35.33 |  |
| 2579 | 1.8.9.6.5.2.4 | Meter Location and Number of Displayed Register Digits Complete | milestone | 0d | 2025-01-24 | 2025-01-24 | 2578 |  |  | 2025-01-31 | 2025-01-31 | 0d |  |  | 32332d |  |  |  |  |  | Transition | 5.4 | Matthew Breen | Migration | Green | GREEN |  |  |  | 35.71 |  |
| 2580 | 1.8.9.6.6 | **Registration Data** |  | 289d | 2024-09-06 A | 2025-10-15 |  | 81% | 55.05d | 2024-09-06 | 2025-09-03 | 147d |  |  | 32144d |  |  |  | N/A | N/A | Transition | 5.4 | N/A | Migration |  |  |  |  |  |  |  |
| 2581 | 1.8.9.6.6.1 | **Connection Type** |  | 47d | 2024-09-06 A | 2024-11-11 A |  | 100% |  | 2024-09-06 | 2024-11-11 | 16d |  |  |  |  |  |  | N/A | N/A | Transition | 5.4 | N/A | Migration |  |  |  |  |  |  |  |
| 2582 | 1.8.9.6.6.1.1 | Automated Population of Connection Type for Measurement Classes ‘B’, ‘D’, ‘F’ & ‘G’ | milestone | 0d | 2024-10-04 A | 2024-10-04 A | 2567FS+317d | 100% |  | 2024-10-04 | 2024-10-04 | 0d |  |  |  |  | start no earlier than 2024-09-13 |  | LDSO |  | Transition | 5.5 | Matthew Breen | Migration | Complete | COMPLETE | T3-MI-0027 | MCAG (Transition) | T3 |  |  |
| 2583 | 1.8.9.6.6.1.2 | BAU Population of Connection Type for Site Specific LLFCs within Measurement Classes ‘C’ & ‘E’ | milestone | 0d | 2024-10-04 A | 2024-10-04 A | 2567FS+317d | 100% |  | 2024-10-04 | 2024-10-04 | 0d |  |  |  |  |  |  | LDSO |  | Transition | 5.5 | Matthew Breen | Migration | Complete | COMPLETE | T3-MI-0028 | MCAG (Transition) | T3 |  |  |
| 2584 | 1.8.9.6.6.1.3 | Automated Population of Connection Type for Smart Meters within Measurement Class ‘A’ | milestone | 0d | 2024-10-04 A | 2024-10-04 A | 2567FS+317d | 100% |  | 2024-10-04 | 2024-10-04 | 0d |  |  |  |  |  |  | LDSO |  | Transition | 5.5 | Matthew Breen | Migration | Complete | COMPLETE | T3-MI-0029 | MCAG (Transition) | T3 |  |  |
| 2585 | 1.8.9.6.6.1.4 | Population of Connection Type for Traditional and Advanced Meters within Measurement Class ‘A’ |  | 1d | 2024-09-06 A | 2024-09-06 A | 2567FS+296d | 100% |  | 2024-09-06 | 2024-09-06 | 1d |  |  |  |  |  |  | Suppliers |  | Transition | 5.4 | Matthew Breen | Migration | Complete | COMPLETE |  |  |  |  |  |
| 2586 | 1.8.9.6.6.1.5 | Automated Population of Null Connection Type | milestone | 0d | 2024-10-04 A | 2024-10-04 A | 2567FS+317d | 100% |  | 2024-10-04 | 2024-10-04 | 0d |  |  |  |  |  |  | LDSO |  | Transition | 5.5 | Matthew Breen | Migration | Complete | COMPLETE | T3-MI-0030 | MCAG (Transition) | T3 |  |  |
| 2587 | 1.8.9.6.6.1.6 | Full MPAN refresh to ESS |  | 16d | 2024-10-21 A | 2024-11-11 A | 2567FS+327d | 100% |  | 2024-10-21 | 2024-11-11 | 1d |  |  |  |  |  |  | LDSO/EES |  | Transition | 5.4 | Matthew Breen | Migration | Complete | COMPLETE |  |  |  |  | Actually takes place on 29/9/24 which is a Sunday |
| 2588 | 1.8.9.6.6.1.7 | Connection Type Complete | milestone | 0d | 2024-11-11 A | 2024-11-11 A | 2582, 2583, 2584, 2585, 2586, 2587 | 100% |  | 2024-11-11 | 2024-11-11 | 0d |  |  |  |  |  |  |  |  | Transition | 5.4 | Matthew Breen | Migration | Complete | COMPLETE |  |  |  |  |  |

Notes:
- 2574: Action: 2/8/24: is date right as different to baseline? Why was it 23rd?

| ID | WBS | Task | Type | Duration | Start | Finish | Predecessors | Complete | Remaining | Baseline start | Baseline finish | Baseline duration | Baseline 1 start | Baseline 1 finish | Total slack | Free slack | Constraint | Baseline cost | Responsible | Involved | Text9 | Update Version | MHHS Resource Name | MHHS Programme Phase | Guidance | Task Status | Sched Status | RAG | Milestone ID | Text29 | Tier |
| --- | --- | --- | --- | --- | --- | --- | --- | --- | --- | --- | --- | --- | --- | --- | --- | --- | --- | --- | --- | --- | --- | --- | --- | --- | --- | --- | --- | --- | --- | --- | --- |
| 2589 | 1.8.9.6.6.2 | **Domestic Premises Indicator** |  | 19d | 2025-09-19 | 2025-10-15 |  |  |  | 2025-08-08 | 2025-09-03 | 17d |  |  | 32144d |  |  |  | N/A | N/A | Transition | 5.4 | N/A | Migration |  |  |  |  |  |  |  |
| 2590 | 1.8.9.6.6.2.1 | The DCC to extract Domestic Premises Indicator from the CSS and provide a file to each LDSO and EES. |  | 2d | 2025-09-19 | 2025-09-22 | 1774FS-4d |  |  | 2025-09-19 | 2025-09-22 | 1d |  |  | 32144d | 0d | start no earlier than 2025-08-08 |  | DCC |  | Transition | 5.4 | Matthew Breen | Migration | 27/7 - needs to end on date of M10 7/3/25 | 273.33 | Green | GREEN |  |  |  |
| 2591 | 1.8.9.6.6.2.2 | Each LDSO notifies the DCC of any exceptions |  | 1d | 2025-09-23 | 2025-09-23 | 2590 |  |  | 2025-09-23 | 2025-09-23 | 1d |  |  | 32144d | 0d |  |  | LDSO |  | Transition | 5.4 | Matthew Breen | Migration | 27/7 - needs to end on date of M10 7/3/25 | 277.33 | Green | GREEN |  |  |  |
| 2592 | 1.8.9.6.6.2.3 | Each LDSO and DCC completes investigation and resolution of exceptions |  | 1d | 2025-10-15 | 2025-10-15 | 2590FS+15d, 2591FS+15d |  |  | 2025-10-15 | 2025-10-15 | 1d |  |  | 32144d | 0d |  |  | LDSO / DCC |  | Transition | 5.4 | Matthew Breen | Migration | 27/7 Needs to take place approx. 1 month after M10 | 299.33 | Green | GREEN |  |  |  |
| 2593 | 1.8.9.6.6.2.4 | Domestic Premises Indicator Complete | milestone | 0d | 2025-10-15 | 2025-10-15 | 2592 |  |  | 2025-10-15 | 2025-10-15 | 0d |  |  | 32144d |  |  |  |  |  | Transition | 5.4 | Matthew Breen | Migration |  | 299.71 | Green | GREEN |  |  |  |
| 2594 | 1.8.9.6.7 | **Export / Import MPANs** |  | 151d | 2024-03-22 A | 2024-10-18 A |  | 100% |  | 2024-03-22 | 2024-10-18 | 151d |  |  |  |  |  |  | N/A | N/A | Transition | 5.4 | N/A | Migration |  |  |  |  |  |  |  |
| 2595 | 1.8.9.6.7.1 | **Linking of Export / Import MPANS** |  | 151d | 2024-03-22 A | 2024-10-18 A |  | 100% |  | 2024-03-22 | 2024-10-18 | 151d |  |  |  |  |  |  | N/A | N/A | Transition | 5.4 | N/A | Migration |  |  |  |  |  |  |  |
| 2596 | 1.8.9.6.7.1.1 | LDSO utilises BAU processing (DB05s) to populate each import/export association |  | 1d | 2024-03-22 A | 2024-03-22 A | 2567FS+176d | 100% |  | 2024-03-22 | 2024-03-22 | 1d |  |  |  |  |  |  | LDSO |  | Transition | 5.4 | Matthew Breen | Migration |  |  | Complete | COMPLETE |  |  |  |
| 2597 | 1.8.9.6.7.1.2 | Each LDSO notifies the Registered Supplier of any exceptions |  | 1d | 2024-04-19 A | 2024-04-19 A | 2596FS+19d | 100% |  | 2024-04-19 | 2024-04-19 | 1d |  |  |  |  |  |  | LDSO |  | Transition | 5.4 | Matthew Breen | Migration |  |  | Complete | COMPLETE |  |  |  |
| 2598 | 1.8.9.6.7.1.3 | Each Supplier completes investigation and resolution of exceptions |  | 1d | 2024-08-23 A | 2024-08-23 A | 2597FS+89d | 100% |  | 2024-08-23 | 2024-08-23 | 1d |  |  |  |  |  |  | Supplier |  | Transition | 5.4 | Matthew Breen | Migration |  |  | Complete | COMPLETE |  |  |  |
| 2599 | 1.8.9.6.7.1.4 | Each LDSO has linked al relevant import/export MPANS | milestone | 0d | 2024-10-18 A | 2024-10-18 A | 2598FS+40d | 100% |  | 2024-10-18 | 2024-10-18 | 0d |  |  |  |  |  |  | LDSO |  | Transition | 5.5 | Matthew Breen | Migration |  |  | Complete | COMPLETE | T3-MI-0031 | MCAG (Transition) | T3 |
| 2600 | 1.8.9.6.7.1.5 | Linking of Export / Import MPANS Complete | milestone | 0d | 2024-10-18 A | 2024-10-18 A | 2599 | 100% |  | 2024-10-18 | 2024-10-18 | 0d |  |  |  |  |  |  |  |  | Transition | 5.4 | Matthew Breen | Migration |  |  | Complete | COMPLETE |  |  |  |
| 2601 | 1.8.9.6.8 | Pre-migration data cleanse complete | milestone | 0d | 2025-08-13 | 2025-08-13 |  |  |  | 2025-08-13 | 2025-08-13 | 0d | 2025-04-04 | 2025-04-04 | 32190d |  | start no earlier than 2025-08-13 |  | SI Migration | PP | Transition | 5.0 | Matthew Breen | Migration |  | 236.33 | Green | GREEN | T2-MI-0450 | MCAG (Transition) | T2 |
| 2602 | 1.8.10 | **Migration Period Planning** |  | 367d | 2023-07-03 A | 2024-11-26 |  | 83% | 61.71d | 2023-07-03 | 2024-11-26 | 851d | 2023-07-03 | 2026-10-05 | 32251d |  |  | -0 | N/A | N/A | Transition | 5.0 | N/A | Migration |  | M10 |  |  |  |  |  |
| 2603 | 1.8.10.1 | **Migration Implementation Plan (incl. Migration Exit Criteria)** |  | 367d | 2023-07-03 A | 2024-11-26 |  | 83% | 61.71d | 2023-07-03 | 2024-11-26 | 851d | 2023-07-03 | 2026-10-05 | 32251d |  |  | -0 | N/A | N/A | Transition | 5.0 | N/A | Migration |  |  |  |  |  |  |  |
| 2604 | 1.8.10.1.1 | **Migration Threshold Volumes** |  | 101d | 2023-07-03 A | 2023-11-20 A |  | 100% |  | 2023-07-03 | 2023-11-20 | 98d | 2023-07-03 | 2023-08-31 |  |  |  | -0 | N/A | N/A | Transition | 5.0 | N/A | Migration |  |  |  |  |  |  |  |
| 2605 | 1.8.10.1.1.1 | Threshold volumes reviewed by MWG |  | 54d | 2023-07-03 A | 2023-09-14 A |  | 100% |  | 2023-07-03 | 2023-09-14 | 54d | 2023-07-03 | 2023-07-28 |  |  |  |  | SI Migration | PP | Transition | 5.6 | John Wiggins,Matthew Breen | Migration |  |  | Complete | COMPLETE |  |  |  |
| 2606 | 1.8.10.1.1.2 | Artefact review (via TMAG) and updates |  | 47d | 2023-09-15 A | 2023-11-20 A | 2605 | 100% |  | 2023-09-15 | 2023-11-20 | 44d | 2023-07-31 | 2023-08-31 |  |  |  |  | PP | SI Migration | Transition | 5.9 | John Wiggins,Matthew Breen | Migration |  |  | Complete | COMPLETE |  |  |  |
| 2607 | 1.8.10.1.1.3 | Threshold volumes approved at TMAG | milestone | 0d | 2023-11-20 A | 2023-11-20 A | 2606 | 100% |  | 2023-11-20 | 2023-11-20 | 0d | 2023-08-31 | 2023-08-31 |  |  |  |  | SI Migration | PP | Transition | 5.12 | John Wiggins,Matthew Breen | Migration |  |  | Complete | COMPLETE | T3-MI-0021 | SITAG | T3 |
| 2608 | 1.8.10.1.2 | **Define acceptance criteria for M15** |  | 78d | 2023-09-04 A | 2023-12-20 A |  | 100% |  | 2023-09-04 | 2023-12-20 | 78d | 2023-09-04 | 2023-11-30 |  |  |  | -0 | N/A | N/A | Transition | 5.0 | N/A | Migration |  |  |  |  |  |  |  |
| 2609 | 1.8.10.1.2.1 | Review acceptance criteria and reporting requirements with MWG |  | 49d | 2023-09-04 A | 2023-11-09 A |  | 100% |  | 2023-09-04 | 2023-11-09 | 40d | 2023-09-04 | 2023-10-27 |  |  | start no earlier than 2023-09-04 |  | SI Migration |  | Transition | 5.0 | John Wiggins,Matthew Breen | Migration |  |  | Complete | COMPLETE |  |  |  |
| 2610 | 1.8.10.1.2.2 | Artefact review (via TMAG) and updates |  | 29d | 2023-11-10 A | 2023-12-20 A | 2609 | 100% |  | 2023-11-10 | 2023-12-20 | 29d | 2023-10-30 | 2023-11-30 |  |  | start no earlier than 2023-10-30 |  | PP | SI Migration | Transition | 5.0 | John Wiggins,Matthew Breen | Migration |  |  | Complete | COMPLETE |  |  |  |
| 2611 | 1.8.10.1.2.3 | Acceptance criteria for M15 agreed at TMAG | milestone | 0d | 2023-12-20 A | 2023-12-20 A | 2610 | 100% |  | 2023-12-20 | 2023-12-20 | 0d | 2023-11-30 | 2023-11-30 |  |  | finish no earlier than 2023-11-30 |  | SI Migration |  | Transition | 5.14 | John Wiggins,Matthew Breen | Migration |  |  | Complete | COMPLETE | T3-MI-0022 | SITAG | T3 |
| 2612 | 1.8.10.1.3 | **M10/M11 cut-over plan** |  | 119d | 2023-12-21 A | 2024-06-04 A |  | 100% |  | 2023-12-21 | 2024-06-04 | 119d | 2024-01-01 | 2024-05-31 |  |  |  | -0 | N/A | N/A | Transition | 5.16 | N/A | Migration |  |  |  |  |  |  |  |
| 2613 | 1.8.10.1.3.1 | Draft Document |  | 84d | 2023-12-21 A | 2024-04-16 A | 2611 | 100% |  | 2023-12-21 | 2024-04-16 | 84d |  |  |  |  |  |  | SI Transition | SI Transition,PP,SRO | Transition | 5.16 | Matthew Breen | Migration |  |  | Complete | COMPLETE |  |  |  |
| 2614 | 1.8.10.1.3.2 | Share Document with SRO |  | 1d | 2024-04-17 A | 2024-04-17 A | 2613 | 100% |  | 2024-04-17 | 2024-04-17 | 1d |  |  |  |  |  |  | SI Transition | SI Transition,PP,SRO | Transition | 5.16 | Matthew Breen | Migration |  |  | Complete | COMPLETE |  |  |  |
| 2615 | 1.8.10.1.3.3 | Industry Consultation |  | 11d | 2024-04-23 A | 2024-05-07 A | 2614FS+3d | 100% |  | 2024-04-23 | 2024-05-07 | 11d |  |  |  |  |  |  | SI Transition | SI Transition,PP,SRO | Transition | 5.16 | Matthew Breen | Migration |  |  | Complete | COMPLETE |  |  |  |
| 2616 | 1.8.10.1.3.4 | Assurance Meeting |  | 1d | 2024-05-21 A | 2024-05-21 A | 2615FS+9d | 100% |  | 2024-05-21 | 2024-05-21 | 1d |  |  |  |  |  |  | SI Transition | SI Transition,PP,SRO | Transition | 5.16 | Matthew Breen | Migration |  |  | Complete | COMPLETE |  |  |  |
| 2617 | 1.8.10.1.3.5 | MCAG Approval of M10/M11 Cut-over Plan | milestone | 0d | 2024-06-04 A | 2024-06-04 A | 2616FS+10d | 100% |  | 2024-06-04 | 2024-06-04 | 0d | 2024-05-31 | 2024-05-31 |  |  |  |  | SI Transition | SI Transition,PP,SRO | Transition | 5.26 | Matthew Breen | Migration |  |  | Complete | COMPLETE | T3-MI-0023 | MCAG | T3 |

| ID | WBS | Task | Type | Duration | Start | Finish | Predecessors | Complete | Remaining | Baseline start | Baseline finish | Baseline duration | Baseline 1 start | Baseline 1 finish | Total slack | Free slack | Constraint | Baseline cost | Responsible | Involved | Text9 | Update Version | MHHS Resource Name | MHHS Programme Phase | Sched Status | RAG | Task Status | Milestone ID | Text29 | Tier | Action |
| --- | --- | --- | --- | --- | --- | --- | --- | --- | --- | --- | --- | --- | --- | --- | --- | --- | --- | --- | --- | --- | --- | --- | --- | --- | --- | --- | --- | --- | --- | --- | --- |
| 2618 | 1.8.10.1.4 | **M16 Methodology** |  | 85d | 2024-07-31 A | 2024-11-26 |  | 10% | 76.9d | 2024-07-31 | 2024-11-26 | 85d | 2023-10-02 | 2024-04-26 | 32251d |  |  | -0 | N/A | N/A | Transition | 5.0 | N/A | Migration |  |  |  |  |  |  |  |
| 2619 | 1.8.10.1.4.1 | Draft Document |  | 50d | 2024-07-31 A | 2024-10-08 |  | 12% | 44d | 2024-07-31 | 2024-10-08 | 50d | 2023-10-02 | 2023-12-29 | 32251d | 0d |  |  | SI Transition | SI Transition,PP,SRO | Transition | 5.26 | Matthew Breen | Migration | Overdue | RED |  |  |  |  |  |
| 2620 | 1.8.10.1.4.2 | Share Document with SRO |  | 1d | 2024-10-09 | 2024-10-09 | 2619 |  |  | 2024-10-09 | 2024-10-09 | 1d | 2024-01-01 | 2024-01-26 | 32251d | 0d |  |  | SI Transition | SI Transition,PP,SRO | Transition | 5.26 | Matthew Breen | Migration | Overdue Start | RED | -71.67 |  |  |  |  |
| 2621 | 1.8.10.1.4.3 | Industry Consultation |  | 11d | 2024-10-15 | 2024-10-29 | 2620FS+3d |  |  | 2024-10-15 | 2024-10-29 | 11d | 2024-01-29 | 2024-03-29 | 32251d | 0d |  |  | SI Transition | SI Transition,PP,SRO | Transition | 5.26 | Matthew Breen | Migration | Overdue Start | RED | -65.67 |  |  |  |  |
| 2622 | 1.8.10.1.4.4 | Assurance Meeting |  | 1d | 2024-11-12 | 2024-11-12 | 2621FS+9d |  |  | 2024-11-12 | 2024-11-12 | 1d | 2024-04-01 | 2024-04-26 | 32251d | 0d |  |  | SI Transition | SI Transition,PP,SRO | Transition | 5.26 | Matthew Breen | Migration | Green | RED | -37.67 |  |  |  |  |
| 2623 | 1.8.10.1.4.5 | M16 methodology approved | milestone | 0d | 2024-11-26 | 2024-11-26 | 2622FS+10d |  |  | 2024-11-26 | 2024-11-26 | 0d | 2024-04-26 | 2024-04-26 | 32251d | 678d |  |  | SI Transition | SI Transition,PP,SRO | Transition | 5.26 | Matthew Breen | Migration | Green | RED | -23.29 | T3-MI-0500 | MCAG (Transition) | T2 |  |
| 2624 | 1.8.11 | **Preparation for Cutover to Live** |  | 341d | 2024-06-28 A | 2025-10-17 |  |  | 341d | 2024-06-28 | 2025-10-22 | 201d | 2025-02-07 | 2025-04-04 | 32142d |  |  | -0 | N/A | N/A | Transition | 6.11 | N/A | Migration |  |  |  |  |  |  |  |
| 2625 | 1.8.11.1 | **Central Systems Prepare for Cutover to Live** |  | 326d | 2024-06-28 A | 2025-09-26 |  |  | 326d | 2024-06-28 | 2025-09-26 | 186d | 2025-02-07 | 2025-03-07 | 32157d |  |  | -0 | N/A | N/A | Transition | 6.11 | N/A | Migration |  |  | M13 |  |  |  |  |
| 2626 | 1.8.11.1.1 | DCC (Functionality available June 2024) | milestone | 0d | 2024-06-28 A | 2024-06-28 A |  | 100% |  | 2024-06-28 | 2024-06-28 | 0d |  |  |  |  | start no earlier than 2024-06-28 |  | DCC |  | Transition | 6.11 | Matthew Breen |  | Complete | COMPLETE |  |  |  |  |  |
| 2627 | 1.8.11.1.2 | **Development of Comms Approach and Declaration Guidance** |  | 79d | 2025-04-28 | 2025-08-14 |  |  |  | 2025-03-03 | 2025-06-19 | 79d |  |  | 31607d |  |  |  | N/A | N/A | Transition | 6.11 | N/A |  |  |  | 95.33 |  |  |  |  |
| 2628 | 1.8.11.1.2.1 | Draft Cutover Comms Approach |  | 59d | 2025-04-28 | 2025-07-17 |  |  |  | 2025-04-28 | 2025-07-17 | 59d |  |  | 31607d | 0d | start no earlier than 2025-04-28 |  | SI Transition | SI Transition | Transition | 6.11 | Matthew Breen |  | Green | GREEN | 129.33 |  |  |  |  |
| 2629 | 1.8.11.1.2.2 | Draft Cutover Comms Approach shared | milestone | 0d | 2025-07-17 | 2025-07-17 | 2628 |  |  | 2025-07-17 | 2025-07-17 | 0d |  |  | 31607d | 0d |  |  | SI Transition | SI Transition | Transition | 6.11 | Matthew Breen |  | Green | GREEN | 209.71 |  |  |  |  |
| 2630 | 1.8.11.1.2.3 | Development of Implementation Group |  | 59d | 2025-04-28 | 2025-07-17 |  |  |  | 2025-04-28 | 2025-07-17 | 59d |  |  | 31607d | 0d | start no earlier than 2025-04-28 |  | SI Transition | SI Transition | Transition | 6.11 | Matthew Breen |  | Green | GREEN | 129.33 |  |  |  |  |
| 2631 | 1.8.11.1.2.4 | Implementation Group Established | milestone | 0d | 2025-07-17 | 2025-07-17 | 2630 |  |  | 2025-07-17 | 2025-07-17 | 0d |  |  | 31607d | 0d |  |  | SI Transition | SI Transition | Transition | 6.11 | Matthew Breen |  | Green | GREEN | 209.71 |  |  |  |  |
| 2632 | 1.8.11.1.2.5 | Finalised Cutover Comms Approach shared | milestone | 0d | 2025-08-14 | 2025-08-14 | 2629FS+20d, 2631FS+20d |  |  | 2025-08-14 | 2025-08-14 | 0d |  |  | 31607d | 29d |  |  | SI Transition | SI Transition | Transition | 6.11 | Matthew Breen |  | Green | GREEN | 237.71 |  |  |  |  |
| 2633 | 1.8.11.1.3 | **Development of Cutover Plan requirements with Participants** |  | 94d | 2025-04-28 | 2025-09-04 |  |  |  | 2025-03-03 | 2025-08-06 | 59d |  |  | 31592d |  |  |  | N/A | N/A | Transition | 6.11 | N/A |  |  |  | -605.67 |  |  |  |  |
| 2634 | 1.8.11.1.3.1 | Development of SIT Participant Cutover Plans |  | 59d | 2025-04-28 | 2025-07-17 |  |  |  | 2025-04-28 | 2025-07-17 | 59d |  |  | 31592d | 0d | start no earlier than 2025-04-28 |  | SI Transition | SI Transition | Transition | 6.11 | Matthew Breen |  | Green | GREEN | 129.33 |  |  |  |  |
| 2635 | 1.8.11.1.3.2 | SIT Participant Cutover Plans Ready | milestone | 0d | 2025-07-17 | 2025-07-17 | 2634 |  |  | 2025-07-17 | 2025-07-17 | 0d |  |  | 31592d | 0d |  |  | SI Transition | SI Transition | Transition | 6.11 | Matthew Breen |  | Green | GREEN | 209.71 |  |  |  |  |
| 2636 | 1.8.11.1.3.3 | Programme SIT Participant Cutover Plan Assurance |  | 35d | 2025-07-18 | 2025-09-04 | 2635 |  |  | 2025-07-18 | 2025-09-17 | 44d |  |  | 31592d | 14d |  |  | SI Transition | SI Transition | Transition | 6.11 | Matthew Breen |  | Green | GREEN | 210.33 |  |  |  |  |
| 2637 | 1.8.11.1.4 | **M10/M11 Cutover Activities** |  | 15d | 2025-09-05 | 2025-09-26 |  |  |  | 2025-04-14 | 2025-09-26 | 15d |  |  | 31585d |  |  | -0 |  |  | Transition | 6.11 |  |  |  |  | -608.67 |  |  |  |  |
| 2638 | 1.8.11.1.4.1 | Production DIP Portal (DIP Deployment) | milestone | 0d | 2025-09-05 | 2025-09-05 | 1633FS+10d |  |  | 2025-09-05 | 2025-09-05 | 0d |  |  | 31585d | 7d |  |  | Elexon,DIP Manager | Elexon,DIP Manager, SI Transition | Transition | 6.11 | Matthew Breen |  | Green | GREEN | 259.71 |  |  |  |  |
| 2639 | 1.8.11.1.4.2 | Production Certificates (DIP Deployment) | milestone | 0d | 2025-09-05 | 2025-09-05 | 1633FS+10d |  |  | 2025-09-05 | 2025-09-05 | 0d |  |  | 31585d | 7d |  |  | Elexon,DIP Manager | Elexon,DIP Manager, SI Transition | Transition | 6.11 | Matthew Breen |  | Green | GREEN | 259.71 |  |  |  |  |
| 2640 | 1.8.11.1.4.3 | Completion of the pre-M10 MHHS Data Cleanse | milestone | 0d | 2025-09-24 | 2025-09-24 | 1774 |  |  | 2025-09-24 | 2025-09-24 | 0d |  |  | 32159d |  |  |  | PP,DCC,SI Transition | PP,DCC,SI Transition | Transition | 6.11 | Matthew Breen |  | Green | GREEN | 278.71 |  |  |  |  |
| 2641 | 1.8.11.1.4.4 | Market-wide Participant MHHS Supporting Functionality Ready - Confirmation from Code Bodies | milestone | 0d | 2025-09-15 | 2025-09-15 | 1774FS-8d |  |  | 2025-09-15 | 2025-09-15 | 0d |  |  | 32167d |  |  |  | Code Bodies | Code Bodies,SI Transition | Transition | 6.11 | Matthew Breen |  | Green | GREEN | 269.33 |  |  |  |  |
| 2642 | 1.8.11.1.4.5 | Market-wide Participant MHHS Supporting Functionality Ready | milestone | 0d | 2025-09-22 | 2025-09-22 | 1774FS-3d |  |  | 2025-09-22 | 2025-09-22 | 0d |  |  | 32162d |  |  |  | PP | PP,SI Transition | Transition | 6.11 | Matthew Breen |  | Green | GREEN | 276.33 |  |  |  |  |
| 2643 | 1.8.11.1.4.6 | Elexon Central Services Deployment | milestone | 0d | 2025-09-19 | 2025-09-19 | 2665 |  |  | 2025-09-19 | 2025-09-19 | 0d |  |  | 31578d | 0d |  |  | DIP Manager,Elexon | DIP Manager,Elexon,SI Transition | Transition | 6.11 | Matthew Breen |  | Green | GREEN | 273.71 |  |  |  |  |
| 2644 | 1.8.11.1.4.7 | Service Management Go-Live | milestone | 0d | 2025-09-19 | 2025-09-19 | 2665 |  |  | 2025-09-19 | 2025-09-19 | 0d |  |  | 31578d | 0d |  |  | Elexon | Elexon,SI Transition | Transition | 6.11 | Matthew Breen |  | Green | GREEN | 273.71 |  |  |  |  |
| 2645 | 1.8.11.1.4.8 | Data Transfer Service (DTS) New Functionality Deployment | milestone | 0d | 2025-09-19 | 2025-09-19 | 2665 |  |  | 2025-09-19 | 2025-09-19 | 0d |  |  | 31578d | 0d |  |  | Code Bodies,Electralink | Code Bodies,SI Transition | Transition | 6.11 | Matthew Breen |  | Green | GREEN | 273.71 |  |  |  |  |
| 2646 | 1.8.11.1.4.9 | Electricity Enquiry Service (EES) Deployment | milestone | 0d | 2025-09-19 | 2025-09-19 | 2665 |  |  | 2025-09-19 | 2025-09-19 | 0d |  |  | 31578d | 0d |  |  | Code Bodies | Code Bodies,SI Transition | Transition | 6.11 | Matthew Breen |  | Green | GREEN | 273.71 |  |  |  |  |
| 2647 | 1.8.11.1.4.10 | MPRS, UMSO Role, LDSO Role Operational | milestone | 0d | 2025-09-19 | 2025-09-19 | 2665 |  |  | 2025-09-19 | 2025-09-19 | 0d |  |  | 31578d | 0d |  |  | PP | SI Transition,PP | Transition | 6.11 | Matthew Breen |  | Green | GREEN | 273.71 |  |  |  |  |
| 2648 | 1.8.11.1.4.11 | Population of Domestic Premises Indicator | milestone | 0d | 2025-09-19 | 2025-09-19 | 2665 |  |  | 2025-09-19 | 2025-09-19 | 0d |  |  | 31578d | 0d |  |  | PP,DCC,SI Transition | PP,DCC,SI Transition | Transition | 6.11 | Matthew Breen |  | Green | GREEN | 273.71 |  |  |  |  |
| 2649 | 1.8.11.1.4.12 | Population of Market Segment | milestone | 0d | 2025-09-19 | 2025-09-19 | 2665 |  |  | 2025-09-19 | 2025-09-19 | 0d |  |  | 31578d | 0d |  |  | PP,SI Transition | PP,SI Transition | Transition | 6.11 | Matthew Breen |  | Green | GREEN | 273.71 |  |  |  |  |
| 2650 | 1.8.11.1.4.13 | Early Life Support Implemented | milestone | 0d | 2025-09-19 | 2025-09-19 | 2665 |  |  | 2025-09-19 | 2025-09-19 | 0d |  |  | 31581d | 3d |  |  | SI Transition,Elexon,Central Services | SI Transition,Elexon,Central Services | Transition | 6.11 | Matthew Breen |  | Green | GREEN | 273.71 |  |  |  |  |
| 2651 | 1.8.11.1.4.14 | MCC Tested and Ready to Operate | milestone | 0d | 2025-09-19 | 2025-09-19 |  |  |  | 2025-09-19 | 2025-09-19 | 0d |  |  | 32163d | 0d | start no earlier than 2025-09-19 |  | SI Migration | SI Migration | Transition | 6.11 | Matthew Breen |  | Green | GREEN | 273.33 |  |  |  | 1/7: To link into migration/service activation |
| 2652 | 1.8.11.1.4.15 | MCC Operational | milestone | 0d | 2025-09-19 | 2025-09-19 | 2651 |  |  | 2025-09-19 | 2025-09-19 | 0d |  |  | 32163d |  |  |  | SI Migration | SI Migration | Transition | 6.11 | Matthew Breen |  | Green | GREEN | 273.33 |  |  |  | 1/7: To link into migration/service activation |
| 2653 | 1.8.4.1.4 | Central Systems live and Codes designated at 00:00 | milestone | 0d | 2025-09-22 | 2025-09-22 | 2643FS+1d, 2644FS+1d, 2645FS+1d, 2646FS+1d, 2647FS+1d, 2648FS+1d, 2649FS+1d, 2626FS+1d |  |  | 2025-09-22 | 2025-09-22 | 0d |  |  | 31578d | 0d |  |  | SI Transition | SI Transition | Transition | 6.11 | Matthew Breen |  | Green | GREEN | 276.71 | T3-MI-0034 | MCAG (Transition) | T3 |  |
| 2654 | 1.8.11.1.4.17 | SIT Participant Qualification - The final date by which participant qualification status can be confirmed for participants to be ready for the start of Migration at M11. | milestone | 0d | 2025-09-26 | 2025-09-26 | 1633FS+25d |  |  | 2025-09-26 | 2025-09-26 | 0d |  |  | 31592d | 11d |  |  | PP,Code Bodies,BSC PAB | SI Transition,PP,Code Bodies,BSC PAB | Transition | 6.11 | Matthew Breen |  | Green | GREEN | 280.71 |  |  |  |  |

Notes:
- 2623: 17/12/24 - Production of this artefact has been delayed. M16 decision making process to be reviewed in Jan 2025 following CR055.
- 2641: 09/10/24 - WR and Fola O extended duration by 110d so the activity completes at 04/08/25.
- 2642: 09/10/24 - WR and Fola O reduced the lag so the activity completes at 11/08/25.
- 2653: Guidance: 25/7/24: New Milestone approved at MCAG on 25/7/24. It was initially approved at MCAG on 4/6 but didn't follow the usual process so addded to July MCAG for noting

| ID | WBS | Task | Type | Duration | Start | Finish | Predecessors | Baseline start | Baseline finish | Baseline duration | Total slack | Free slack | Constraint | Responsible | Involved | Text9 | Task Status | Update Version | MHHS Resource Name | Sched Status | RAG | Milestone ID | Text29 | Tier |
| --- | --- | --- | --- | --- | --- | --- | --- | --- | --- | --- | --- | --- | --- | --- | --- | --- | --- | --- | --- | --- | --- | --- | --- | --- |
| 2655 | 1.8.11.2 | **Cutover Governance M10** |  | 11d | 2025-09-10 | 2025-09-24 |  | 2025-07-30 | 2025-09-24 | 27d | 31581d |  |  | N/A | N/A | Transition | -595.67 | 6.11 | N/A |  |  |  |  |  |
| 2656 | 1.8.11.2.1 | Confirmation that Pre-migration Data Cleanse Activities have successfully taken place | milestone | 0d | 2025-09-10 | 2025-09-10 |  | 2025-09-10 | 2025-09-10 | 0d | 31583d | 5d | start no earlier than 2025-09-10 | PP | SI Transition,PP | Transition | 264.33 | 6.11 | Matthew Breen | Green | GREEN |  |  |  |
| 2657 | 1.8.11.2.2 | Confirmation of Helix E2E Settlement Testing Complete | milestone | 0d | 2025-09-15 | 2025-09-15 |  | 2025-09-15 | 2025-09-15 | 0d | 31580d | 2d | start no earlier than 2025-09-15 |  |  | Transition | 269.33 | 6.11 |  | Green | GREEN |  |  |  |
| 2658 | 1.8.11.2.3 | Confirmation of assurance of Helix E2E Settlement Testing | milestone | 0d | 2025-09-15 | 2025-09-15 |  | 2025-09-15 | 2025-09-15 | 0d | 31580d | 2d | start no earlier than 2025-09-15 |  |  | Transition | 269.33 | 6.11 |  | Green | GREEN |  |  |  |
| 2659 | 1.8.11.2.4 | Confirmation of Qualification Status for SIT MVC | milestone | 0d | 2025-09-15 | 2025-09-15 |  | 2025-09-15 | 2025-09-15 | 0d | 31580d | 2d | start no earlier than 2025-09-15 | SIT MVC,Code Bodies | SI Transition,SIT MVC,Code Bodies | Transition | 269.33 | 6.11 | Matthew Breen | Green | GREEN |  |  |  |
| 2660 | 1.8.11.2.5 | Confirmation of Qualification Status for Non-SIT LDSOs | milestone | 0d | 2025-09-15 | 2025-09-15 |  | 2025-09-15 | 2025-09-15 | 0d | 31580d | 2d | start no earlier than 2025-09-15 | PP,Code Bodies | SI Transition,PP,Code Bodies | Transition | 269.33 | 6.11 | Matthew Breen | Green | GREEN |  |  |  |
| 2661 | 1.8.11.2.6 | Confirmation of Qualification Status of at least one Supplier and their contracted Agents | milestone | 0d | 2025-09-15 | 2025-09-15 |  | 2025-09-15 | 2025-09-15 | 0d | 31580d | 2d | start no earlier than 2025-09-15 | S&A Qualification | SI Transition,S&A Qualification | Transition | 269.33 | 6.11 | Matthew Breen | Green | GREEN |  |  |  |
| 2662 | 1.8.11.2.7 | Declaration from all Central Services and LDSOs that they are in a position to move forwards | milestone | 0d | 2025-09-15 | 2025-09-15 |  | 2025-09-15 | 2025-09-15 | 0d | 31581d | 3d | start no earlier than 2025-09-15 | DIP Manager,Elexon,PP,Code Bodies | SI Transition,DIP Manager,Elexon,PP,Code Bodies | Transition | 269.33 | 6.11 | Matthew Breen | Green | GREEN |  |  |  |
| 2663 | 1.8.11.2.8 | Market-wide Participant MHHS Migration Supporting Functionality is Live | milestone | 0d | 2025-09-15 | 2025-09-15 |  | 2025-09-15 | 2025-09-15 | 0d | 31581d | 3d | start no earlier than 2025-09-15 |  |  | Transition | 269.33 | 6.11 |  | Green | GREEN |  |  |  |
| 2664 | 1.8.11.2.9 | TORWG (Recommendation from TORWG that the Programme should enter M10) | milestone | 0d | 2025-09-17 | 2025-09-17 | 2656FS+1d, 2659FS+1d, 2661FS+1d, 2638FS+1d, 2639FS+1d, 2747FS+1d, 2657FS+1d, 2658FS+1d, 2660FS+1d, 2662, 2663 | 2025-09-17 | 2025-09-17 | 0d | 31578d | 0d |  | SI Transition | SI Transition | Transition | 271.71 | 6.11 | Matthew Breen | Green | GREEN |  |  |  |
| 2665 | 1.8.4.1.4 | MCAG (Confirm that the Programme can Enter M10) | milestone | 0d | 2025-09-19 | 2025-09-19 | 2664FS+2d, 2753 | 2025-09-19 | 2025-09-19 | 0d | 31578d | 0d |  | SI Migration | SI Transition,SI Migration | Transition | 273.71 | 6.11 | Matthew Breen | Green | GREEN | T3-MI-0035 | MCAG (Transition) | T3 |
| 2666 | 1.8.11.2.11 | Self-Declaration from all Central Services and LDSOs that Cutover activities have been successfully carried out | milestone | 0d | 2025-09-22 | 2025-09-22 | 2665FS+1d | 2025-09-22 | 2025-09-22 | 0d | 31581d | 0d |  | PP,DCC,Code Bodies | SI Transition,PP,DCC,Code Bodies | Transition | 276.71 | 6.11 | Matthew Breen | Green | GREEN |  |  |  |
| 2667 | 1.8.11.2.12 | Confirmation that DIP and ECS have been deployed, Service management is active, ISD has been populated | milestone | 0d | 2025-09-22 | 2025-09-22 | 2665FS+1d | 2025-09-22 | 2025-09-22 | 0d | 31581d | 0d |  | Elexon,DIP Manager | SI Transition,Elexon,DIP Manager | Transition | 276.71 | 6.11 | Matthew Breen | Green | GREEN |  |  |  |
| 2668 | 1.8.11.2.13 | Self-Declarations against all M10 Data Cleanse Activities | milestone | 0d | 2025-09-22 | 2025-09-22 | 2665FS+1d | 2025-09-22 | 2025-09-22 | 0d | 31581d | 0d |  | PP | SI Transition,PP | Transition | 276.71 | 6.11 | Matthew Breen | Green | GREEN |  |  |  |
| 2669 | 1.8.11.2.14 | IF-047 has been sent | milestone | 0d | 2025-09-22 | 2025-09-22 | 2665FS+1d | 2025-09-22 | 2025-09-22 | 0d | 31581d | 0d |  | ECS | SI Transition,ECS | Transition | 276.71 | 6.11 | Matthew Breen | Green | GREEN |  |  |  |
| 2670 | 1.8.11.2.15 | Recommendation from TORWG that PSG should approve M10 | milestone | 0d | 2025-09-23 | 2025-09-23 | 2666FS+1d, 2667FS+1d, 2668FS+1d, 2669FS+1d, 2751 | 2025-09-23 | 2025-09-23 | 0d | 31581d | 0d |  | SI Transition | SI Transition | Transition | 277.71 | 6.11 | Matthew Breen | Green | GREEN |  |  |  |
| 2671 | 1.8.11.2.16 | PSG (OFGEM and PSG to Approve That Conditions of M10 and M13 Have Been Met) | milestone | 0d | 2025-09-24 | 2025-09-24 | 2670FS+1d | 2025-09-24 | 2025-09-24 | 0d | 31581d | 0d |  | SI Transition,Ofgem | SI Transition,Ofgem | Transition | 278.71 | 6.11 | Matthew Breen | Green | GREEN |  |  |  |
| 2672 | 1.8.11.3 | **Cutover Governance M11** |  | 16d | 2025-09-26 | 2025-10-17 |  | 2025-09-26 | 2025-10-22 | 0d | 31581d |  |  |  |  | Transition | -687.67 | 6.11 |  |  |  |  |  |  |
| 2673 | 1.8.11.3.1 | Confirmation of Qualified Parties from Code Bodies |  | 11d | 2025-09-26 | 2025-10-10 | 2671FS+1d | 2025-09-26 | 2025-10-10 | 11d | 31581d | 0d |  | Code Bodies,SIT Participants | SI Transition,Code Bodies,SIT Participants | Transition | 280.33 | 6.11 | Matthew Breen | Green | GREEN |  |  |  |
| 2674 | 1.8.11.3.2 | Self-Declaration that MHHS Functionality will be deployed to Production by Qualified parties | milestone | 0d | 2025-10-10 | 2025-10-10 | 2671FS+12d | 2025-10-10 | 2025-10-10 | 0d | 31581d | 0d |  | PP | SI Transition,PP | Transition | 294.71 | 6.11 | Matthew Breen | Green | GREEN |  |  |  |
| 2675 | 1.8.11.3.3 | Production Service Activation Activities have taken place | milestone | 0d | 2025-10-10 | 2025-10-10 | 2671FS+12d | 2025-10-10 | 2025-10-10 | 0d | 31581d | 0d |  | PP | SI Transition,PP | Transition | 294.71 | 6.11 | Matthew Breen | Green | GREEN |  |  |  |
| 2676 | 1.8.11.3.4 | TORWG (Confirmation of Qualified Parties from TORWG) | milestone | 0d | 2025-10-13 | 2025-10-13 | 2673FS+1d, 2674FS+1d, 2675FS+1d, 2654, 2748, 2752 | 2025-10-13 | 2025-10-13 | 0d | 31581d | 0d |  | SI Transition | SI Transition | Transition | 297.71 | 6.11 | Matthew Breen | Green | GREEN |  |  |  |
| 2677 | 1.8.11.3.5 | MCAG (Provide recommendation to PSG on M11 decision) | milestone | 0d | 2025-10-15 | 2025-10-15 | 2676FS+2d | 2025-10-15 | 2025-10-15 | 0d | 31581d | 0d |  | SI Migration | SI Transition,SI Migration | Transition | 299.71 | 6.11 | Matthew Breen | Green | GREEN | T3-MI-0036 | MCAG (Transition) | T3 |
| 2678 | 1.8.11.3.6 | PSG (OFGEM and PSG Decision to Confirm M11 and M12) | milestone | 0d | 2025-10-17 | 2025-10-17 | 2677FS+2d | 2025-10-17 | 2025-10-17 | 0d | 31581d | 3d |  | SI Transition | SI Transition | Transition | 301.71 | 6.11 | Matthew Breen | Green | GREEN |  |  |  |

Notes:
- 2665: Guidance: 25/7/24: New Milestone approved at MCAG on 25/7/24. It was initially approved at MCAG on 4/6 but didn't follow the usual process so addded to July MCAG for noting
- 2675: Guidance: 12/8/24: Think this is covered in Service activation prep section below
- 2677: Guidance: 25/7/24: New Milestone approved at MCAG on 25/7/24. It was initially approved at MCAG on 4/6 but didn't follow the usual process so addded to July MCAG for noting

| ID | WBS | Task | Type | Duration | Start | Finish | Predecessors | Complete | Remaining | Baseline start | Baseline finish | Baseline duration | Baseline 1 start | Baseline 1 finish | Total slack | Free slack | Constraint | Baseline cost | Responsible | Involved | Text9 | Task Status | Update Version | MHHS Resource Name | Sched Status | RAG | MHHS Programme Phase |
| --- | --- | --- | --- | --- | --- | --- | --- | --- | --- | --- | --- | --- | --- | --- | --- | --- | --- | --- | --- | --- | --- | --- | --- | --- | --- | --- | --- |
| 2679 | 1.8.12 | **UMS / Advanced Migration** |  | 401d | 2025-10-23 | 2027-05-06 |  |  |  | 2025-10-23 | 2027-05-07 | 391d |  |  | 31574d |  |  | -0 | N/A | N/A | Transition | -555.67 | 6.0 | N/A |  |  |  |
| 2680 | 1.8.12.1 | SIT MVC UMS / Advanced Migration |  | 391d | 2025-10-23 | 2027-04-22 | 2753, 2709 |  |  | 2025-10-23 | 2027-04-22 | 391d |  |  | 31584d | 0d |  |  |  |  | Transition | 307.33 | 6.0 |  | Green | GREEN |  |
| 2681 | 1.8.12.2 | SIT Non-MVC UMS / Advanced Migration |  | 326d | 2025-12-29 | 2027-03-29 | 2776 |  |  | 2026-01-02 | 2027-04-02 | 326d |  |  | 31602d | 29d |  |  |  |  | Transition | 374.33 | 6.0 |  | Green | GREEN |  |
| 2682 | 1.8.12.3 | Wave 1 UMS / Advanced Migration |  | 251d | 2026-05-15 | 2027-04-30 | 2792 |  |  | 2026-05-15 | 2027-04-30 | 261d |  |  | 31578d | 5d |  |  |  |  | Transition | 511.33 | 6.0 |  | Green | GREEN |  |
| 2683 | 1.8.12.4 | Wave 2 UMS / Advanced Migration |  | 217d | 2026-07-02 | 2027-04-30 | 2816 |  |  | 2026-07-01 | 2027-04-29 | 216d |  |  | 31578d | 5d |  |  |  |  | Transition | 559.33 | 6.0 |  | yellow | RED |  |
| 2684 | 1.8.12.5 | Wave 3 UMS / Advanced Migration |  | 182d | 2026-08-14 | 2027-04-26 | 2840 |  |  | 2026-08-27 | 2027-05-07 | 181d |  |  | 31582d | 9d |  |  |  |  | Transition | 602.33 | 6.0 |  | Green | GREEN |  |
| 2685 | 1.8.12.6 | Wave 4 UMS / Advanced Migration |  | 136d | 2026-10-29 | 2027-05-06 | 2864 |  |  | 2026-10-23 | 2027-04-30 | 131d |  |  | 31574d | 1d |  |  |  |  | Transition | 678.33 | 6.0 |  | yellow | RED |  |
| 2686 | 1.8.13 | **Smart / Non-Smart Migration** |  | 401d | 2025-10-23 | 2027-05-06 |  |  |  | 2025-10-23 | 2027-05-07 | 391d |  |  | 31574d |  |  | -0 | N/A | N/A | Transition | -555.67 | 6.0 | N/A |  |  |  |
| 2687 | 1.8.13.1 | SIT MVC Smart / Non-Smart Migration |  | 391d | 2025-10-23 | 2027-04-22 | 2753, 2709 |  |  | 2025-10-23 | 2027-04-22 | 391d |  |  | 31584d | 0d |  |  |  |  | Transition | 307.33 | 6.0 |  | Green | GREEN |  |
| 2688 | 1.8.13.2 | SIT Non-MVC Smart / Non-Smart Migration |  | 326d | 2025-12-29 | 2027-03-29 | 2776 |  |  | 2026-01-02 | 2027-04-02 | 326d |  |  | 31602d | 29d |  |  |  |  | Transition | 374.33 | 6.0 |  | Green | GREEN |  |
| 2689 | 1.8.13.3 | Wave 1 Smart / Non-Smart Migration |  | 251d | 2026-05-15 | 2027-04-30 | 2792 |  |  | 2026-05-15 | 2027-04-30 | 261d |  |  | 31578d | 5d | start no earlier than 2025-10-03 |  |  |  | Transition | 511.33 | 6.0 |  | Green | GREEN |  |
| 2690 | 1.8.13.4 | Wave 2 Smart / Non-Smart Migration |  | 217d | 2026-07-02 | 2027-04-30 | 2816 |  |  | 2026-07-01 | 2027-04-29 | 216d |  |  | 31578d | 5d |  |  |  |  | Transition | 559.33 | 6.0 |  | yellow | RED |  |
| 2691 | 1.8.13.5 | Wave 3 Smart / Non-Smart Migration |  | 182d | 2026-08-14 | 2027-04-26 | 2840 |  |  | 2026-08-27 | 2027-05-07 | 181d |  |  | 31582d | 9d |  |  |  |  | Transition | 602.33 | 6.0 |  | Green | GREEN |  |
| 2692 | 1.8.13.6 | Wave 4 Smart / Non-Smart Migration |  | 136d | 2026-10-29 | 2027-05-06 | 2864 |  |  | 2026-10-23 | 2027-04-30 | 131d |  |  | 31573d | 0d |  |  |  |  | Transition | 678.33 | 6.0 |  | yellow | RED |  |
| 2693 | 1.8.14 | **External Programme Dependency Management** |  | 740d | 2022-10-31 A | 2025-08-29 |  | 66% | 253.44d | 2022-10-31 | 2025-08-29 | 827d | 2022-10-31 | 2025-07-01 | 32177d |  |  | -0 | N/A | N/A | Transition |  | 5.0 | N/A |  |  | Migration |
| 2694 | 1.8.14.1 | **BSC Mod P432 & REC CP R0015** |  | 392d | 2022-10-31 A | 2024-04-30 A |  | 100% |  | 2022-10-31 | 2024-04-30 | 827d | 2022-10-31 | 2025-07-01 |  |  |  | -0 | N/A | N/A | Transition |  | 5.0 | N/A |  |  | Migration |
| 2695 | 1.8.14.1.1 | MHHSP engagement with BSCCo until Ofgem decision |  | 316d | 2022-10-31 A | 2024-01-15 A |  | 100% |  | 2022-10-31 | 2024-01-15 | 400d | 2022-10-31 | 2022-12-30 |  |  |  |  | CPT,SRO Function | Code Bodies | Transition |  | 5.0 | MHHS Programme | Complete | COMPLETE | Migration |
| 2696 | 1.8.14.1.2 | Monitor progress and await implementation date |  | 76d | 2024-01-16 A | 2024-04-30 A | 2695 | 100% |  | 2024-01-16 | 2024-04-30 | 652d | 2023-01-02 | 2025-07-01 |  |  |  |  | CPT,SRO Function | Code Bodies | Transition |  | 5.0 | MHHS Programme | Complete | COMPLETE | Migration |
| 2697 | 1.8.14.2 | **BSC Mod P434** |  | 713d | 2022-10-31 A | 2025-07-23 |  | 57% | 310d | 2022-10-31 | 2025-07-23 | 713d | 2022-10-31 | 2025-07-01 | 32204d |  |  |  | N/A | N/A | Transition |  | 5.0 | N/A |  |  | Migration |
| 2698 | 1.8.14.2.1 | MHHSP engagement with BSCCo until Ofgem decision |  | 61d | 2022-10-31 A | 2023-01-23 A |  | 100% |  | 2022-10-31 | 2023-01-23 | 61d | 2022-10-31 | 2022-12-30 |  |  |  |  | CPT,SRO Function | Code Bodies | Transition |  | 5.0 | MHHS Programme | Complete | COMPLETE | Migration |
| 2699 | 1.8.14.2.2 | Monitor progress and await implementation date |  | 652d | 2023-01-24 A | 2025-07-23 | 2698 | 52% | 310d | 2023-01-24 | 2025-07-23 | 652d | 2023-01-02 | 2025-07-01 | 32204d |  |  |  | CPT,SRO Function | Code Bodies | Transition |  | 5.0 | MHHS Programme | Green | GREEN | Migration |
| 2700 | 1.8.14.3 | **Elexon System Capacity Upgrade** |  | 697d | 2022-10-31 A | 2025-07-01 |  | 58% | 294d | 2022-10-31 | 2025-07-01 | 697d | 2022-10-31 | 2025-07-01 | 32220d |  |  |  | N/A | N/A | Transition |  | 5.0 | N/A |  |  | Migration |
| 2701 | 1.8.14.3.1 | Monitor progress to implementation |  | 697d | 2022-10-31 A | 2025-07-01 |  | 58% | 294d | 2022-10-31 | 2025-07-01 | 697d | 2022-10-31 | 2025-07-01 | 32220d | 0d |  |  | SI Migration | PP | Transition |  | 5.0 | MHHS Programme | Green | GREEN | Migration |
| 2702 | 1.8.14.3.2 | Implementation date | milestone | 0d | 2025-07-01 | 2025-07-01 | 2701 |  |  | 2025-07-01 | 2025-07-01 | 0d | 2025-07-01 | 2025-07-01 | 32220d |  |  |  | PP | SI Migration | Transition | 193.71 | 5.0 | MHHS Programme | Green | GREEN | Migration |

Notes:
- 2682: Guidance: 12/8/24: Made start no earlier, because shorter service actiobal was allowing this to start earlier than the date that had been set
- 2689: Guidance: 12/8/24: Made start no earlier, because shorter service actiobal was allowing this to start earlier than the date that had been set

| ID | WBS | Task | Type | Duration | Start | Finish | Predecessors | Complete | Remaining | Baseline start | Baseline finish | Baseline duration | Baseline 1 start | Baseline 1 finish | Total slack | Free slack | Constraint | Baseline cost | Responsible | Involved | Text9 | Update Version | MHHS Resource Name | MHHS Programme Phase | Task Status | Sched Status | RAG | Milestone ID | Text29 | Tier | Future RAG |
| --- | --- | --- | --- | --- | --- | --- | --- | --- | --- | --- | --- | --- | --- | --- | --- | --- | --- | --- | --- | --- | --- | --- | --- | --- | --- | --- | --- | --- | --- | --- | --- |
| 2703 | 1.8.14.4 | **DCC System Capacity Upgrade** |  | 25d | 2025-07-28 | 2025-08-29 |  |  |  | 2025-07-28 | 2025-08-29 | 25d | 2025-01-13 | 2025-02-14 | 32177d |  |  |  | N/A | N/A | Transition | 5.0 | N/A | Migration |  |  |  |  |  |  |  |
| 2704 | 1.8.14.4.1 | Assurance of DCC capacity upgrade to ensure suitability to support migration |  | 20d | 2025-07-28 | 2025-08-22 | 1774FF-23d |  |  | 2025-07-28 | 2025-08-22 | 20d | 2025-01-13 | 2025-02-07 | 32177d | 0d |  |  | SI Migration | PP | Transition | 5.0 | MHHS Programme | Migration | 220.33 | Green | GREEN |  |  |  |  |
| 2705 | 1.8.14.4.2 | DCC Capacity Upgrade Operational | milestone | 0d | 2025-08-29 | 2025-08-29 | 2704FS+5d |  |  | 2025-08-29 | 2025-08-29 | 0d | 2025-02-14 | 2025-02-14 | 32177d |  |  |  | PP | SI Migration,IPA | Transition | 5.0 | MHHS Programme | Migration | 252.71 | Green | GREEN | T2-MI-0350 | MCAG | T2 |  |
| 2706 | 1.8.15 | **Migration - Tier 1 Milestones** |  | 488d | 2025-09-24 | 2027-08-09 |  |  |  | 2025-09-24 | 2027-08-09 | 477d | 2025-03-07 | 2027-01-05 | 31598d |  |  |  | N/A | N/A | Transition | 5.0 | N/A | Migration |  |  |  |  |  |  |  |
| 2707 | 1.8.15.1 | Load Shaping Service switched on (M13) | milestone | 0d | 2025-09-24 | 2025-09-24 | 1774 |  |  | 2025-09-24 | 2025-09-24 | 0d | 2025-03-07 | 2025-03-07 | 31598d | 0d |  |  | CPT | CPT | Transition | 6.1 | CPT | Migration | 278.71 | Green | GREEN | T1-MI-2000 | PSG | T1 | Load Shaping Service switched on |
| 2708 | 1.8.15.2 | Load Shaping Service switched on (M13*) - Late Exit | milestone | 0d | 2025-12-24 | 2025-12-24 | 2707FS+65d |  |  | 2025-12-24 | 2025-12-24 | 0d | 2025-06-06 | 2025-06-06 | 32094d |  |  |  | CPT | CPT | Transition | 6.1 | CPT | Migration | 369.71 | Green | GREEN | T2-MI-2500 | PSG | T1 | Load Shaping Service switched on |
| 2709 | 1.8.15.3 | Start of 18-month migration for UMS / Advanced (M11) | milestone | 0d | 2025-10-22 | 2025-10-22 | 2707, 2677, 2678, 2753, 1774FS+20d |  |  | 2025-10-22 | 2025-10-22 | 0d | 2025-04-04 | 2025-04-04 | 31578d | 0d |  |  | CPT | CPT | Transition | 6.1 | CPT | Migration | 306.71 | Green | GREEN | T1-MI-3000 | PSG | T1 | Start of 1 year migration for UMS / Advanced |
| 2710 | 1.8.15.4 | Start of 18-month migration for UMS / Advanced (M11*) - Late Exit | milestone | 0d | 2026-01-21 | 2026-01-21 | 2709FS+65d |  |  | 2026-01-21 | 2026-01-21 | 0d | 2025-07-04 | 2025-07-04 | 32074d |  |  |  | CPT | CPT | Transition | 6.1 | CPT | Migration | 397.71 | Green | GREEN | T2-MI-3500 | PSG | T1 | Start of 1 year migration for UMS / Advanced |
| 2711 | 1.8.15.5 | Start of 18-month migration for Smart / Non-smart (M12) | milestone | 0d | 2025-10-22 | 2025-10-22 | 2707, 1774FS+20d |  |  | 2025-10-22 | 2025-10-22 | 0d | 2025-04-04 | 2025-04-04 | 32074d | 0d |  |  | CPT | CPT | Transition | 6.1 | CPT | Migration | 306.71 | Green | GREEN | T1-MI-4000 | PSG | T1 | Start of 1 year migration for Smart / Non-smart |
| 2712 | 1.8.15.6 | Start of 18-month migration for Smart / Non-smart (M12*) - Late Exit | milestone | 0d | 2026-01-21 | 2026-01-21 | 2711FS+65d |  |  | 2026-01-21 | 2026-01-21 | 0d | 2025-07-04 | 2025-07-04 | 32074d |  |  |  | CPT | CPT | Transition | 6.1 | CPT | Migration | 397.71 | Green | GREEN | T2-MI-4500 | PSG | T1 | Start of 1 year migration for Smart / Non-smart |
| 2713 | 1.8.15.7 | Full transition complete (M15) | milestone | 0d | 2027-05-07 | 2027-05-07 | 2680, 2681, 2682, 2683, 2684, 2685, 2687, 2688, 2689, 2690, 2691, 2692FS+1d |  |  | 2027-05-07 | 2027-05-07 | 0d | 2026-10-05 | 2026-10-05 | 31573d | 0d |  |  | CPT | CPT | Transition | 6.1 | CPT | Migration | 868.71 | Green | GREEN | T1-MI-6000 | PSG | T1 | Full transition complete |
| 2714 | 1.8.15.8 | Full transition complete (M15*) - Late Exit | milestone | 0d | 2027-08-09 | 2027-08-09 | 2713FS+66d |  |  | 2027-08-09 | 2027-08-09 | 0d | 2027-01-05 | 2027-01-05 | 31671d |  |  |  | CPT | CPT | Transition | 6.1 | CPT | Migration | 962.71 | Green | GREEN | T2-MI-6500 | PSG | T1 | Full transition complete |
| 2715 | 1.9 | **BUSINESS & OPERATIONAL READINESS** |  | 1344d? | 2022-10-31 A | 2027-12-23 |  | 6% | 1268.57d? | 2022-10-31 | 2027-12-23 | 964d | 2023-03-01 | 2026-12-07 | 31573d |  |  | -0 | N/A | N/A | Business & Operation Readiness |  | N/A | Business & Operational Readiness |  |  |  |  |  |  |  |
| 2716 | 1.9.1 | **Service Management** |  | 983d | 2023-09-19 A | 2027-06-24 |  | 26% | 728.35d | 2023-09-19 | 2027-06-24 | 840d | 2023-03-01 | 2026-12-07 | 31703d |  |  | -0 | N/A | N/A | Business & Operation Readiness | 5.0 | N/A | Business & Operational Readiness |  |  |  |  |  |  |  |
| 2717 | 1.9.1.1 | **Service Management Strategy** |  | 116d | 2023-09-19 A | 2024-02-27 A |  | 100% |  | 2023-09-19 | 2024-02-27 | 116d | 2023-03-01 | 2023-05-31 |  |  |  | -0 | N/A | N/A | Business & Operation Readiness | 5.0 | N/A | Business & Operational Readiness |  |  |  |  |  |  |  |
| 2718 | 1.9.1.1.1 | Develop document with relevant participants (incl. review of the design baseline to ensure service management arrangements are in place across the solution architecture) |  | 84d | 2023-09-19 A | 2024-01-12 A |  | 100% |  | 2023-09-19 | 2024-01-12 | 84d | 2023-03-01 | 2023-04-28 |  |  | start no earlier than 2023-09-19 |  | SI Design |  | Business & Operation Readiness | 5.0 | Matthew Breen | Business & Operational Readiness |  | Complete | COMPLETE |  |  |  |  |
| 2719 | 1.9.1.1.2 | Artefact review (via relevant Advisory Group) and updates |  | 31d | 2024-01-15 A | 2024-02-26 A | 2718 | 100% |  | 2024-01-15 | 2024-02-26 | 31d | 2023-05-01 | 2023-05-24 |  |  |  |  | PP | SI Design,IPA | Business & Operation Readiness | 5.0 | Matthew Breen | Business & Operational Readiness |  | Complete | COMPLETE |  |  |  |  |
| 2720 | 1.9.1.1.3 | Service Management Strategy approved | milestone | 0d | 2024-02-27 A | 2024-02-27 A | 2719FS+1d | 100% |  | 2024-02-27 | 2024-02-27 | 0d | 2023-05-31 | 2023-05-31 |  |  |  |  | SI Design | PP | Business & Operation Readiness | 5.16 | Matthew Breen | Business & Operational Readiness |  | Complete | COMPLETE | T3-BC-0010 | MCAG | T3 |  |
| 2721 | 1.9.1.2 | **Early Life Support Model** |  | 110d | 2024-02-28 A | 2024-07-30 |  | 82% | 20.23d | 2024-02-28 | 2024-07-30 | 110d |  |  | 32460d |  |  | -0 | N/A | N/A | Business & Operation Readiness | 5.16 | Matthew Breen | Business & Operational Readiness | -441.67 |  |  |  |  |  |  |
| 2722 | 1.9.1.2.1 | Draft Document |  | 74d | 2024-02-28 A | 2024-06-10 | 2720 | 96% | 3d | 2024-02-28 | 2024-06-10 | 74d |  |  | 32460d | 0d |  |  | SI Transition | SI Transition,PP,SRO | Business & Operation Readiness | 5.24 | Matthew Breen | Business & Operational Readiness |  | Overdue | RED |  |  |  |  |
| 2723 | 1.9.1.2.2 | Share document with SRO |  | 1d | 2024-06-11 | 2024-06-11 | 2722 |  |  | 2024-06-11 | 2024-06-11 | 1d |  |  | 32460d | 0d |  |  | SI Transition | SI Transition,PP,SRO | Business & Operation Readiness | 5.24 | Matthew Breen | Business & Operational Readiness | -191.67 | Overdue Start | RED |  |  |  |  |
| 2724 | 1.9.1.2.3 | Industry Consultation |  | 11d | 2024-06-18 | 2024-07-02 | 2723FS+4d |  |  | 2024-06-18 | 2024-07-02 | 11d |  |  | 32460d | 0d |  |  | SI Transition | SI Transition,PP,SRO | Business & Operation Readiness | 5.24 | Matthew Breen | Business & Operational Readiness | -184.67 | Overdue Start | RED |  |  |  |  |
| 2725 | 1.9.1.2.4 | Assurance Meeting |  | 1d | 2024-07-16 | 2024-07-16 | 2724FS+9d |  |  | 2024-07-16 | 2024-07-16 | 1d |  |  | 32460d | 0d |  |  | SI Transition | SI Transition,PP,SRO | Business & Operation Readiness | 5.24 | Matthew Breen | Business & Operational Readiness | -156.67 | Overdue Start | RED |  |  |  |  |
| 2726 | 1.9.1.2.5 | MCAG Approval of Early Life Support Model | milestone | 0d | 2024-07-30 | 2024-07-30 | 2725FS+10d |  |  | 2024-07-30 | 2024-07-30 | 0d |  |  | 32460d |  |  |  | SI Transition | PP,SRO,SI Transition | Business & Operation Readiness | 5.24 | Matthew Breen | Business & Operational Readiness | -142.29 | Overdue Start | RED | T3-MI-0033 | MCAG (Transition) | T3 |  |

Notes:
- 2726: 17/12/24 - High level update was shared at December TORWG. Further update on the Transition governance framework will be given at the January TORWG. Early Life Support Model is a part of this framework.

| ID | WBS | Task | Type | Duration | Start | Finish | Predecessors | Baseline start | Baseline finish | Baseline duration | Baseline 1 start | Baseline 1 finish | Total slack | Free slack | Constraint | Baseline cost | Responsible | Involved | Text9 | Update Version | MHHS Resource Name | MHHS Programme Phase | Task Status | Sched Status | RAG |
| --- | --- | --- | --- | --- | --- | --- | --- | --- | --- | --- | --- | --- | --- | --- | --- | --- | --- | --- | --- | --- | --- | --- | --- | --- | --- |
| 2727 | 1.9.1.3 | **Service Management Arrangements Implementation** |  | 456d | 2025-09-25 | 2027-06-24 |  | 2025-09-25 | 2027-06-24 | 453d | 2025-03-10 | 2026-12-07 | 31703d |  |  | -0 | N/A | N/A | Business & Operation Readiness | 5.0 | N/A | Business & Operational Readiness |  |  |  |
| 2728 | 1.9.1.3.1 | Hypercare post M10 |  | 80d | 2025-09-25 | 2026-01-14 | 1774 | 2025-09-25 | 2026-01-14 | 80d | 2025-03-10 | 2025-06-27 | 32079d |  |  |  | SI Design | PP | Business & Operation Readiness | 5.0 | Claire Silk | Business & Operational Readiness | 279.33 | Green | GREEN |
| 2729 | 1.9.1.3.2 | Monitor Elexon implementation of Service Management arrangements |  | 436d | 2025-10-23 | 2027-06-24 | 2680SS, 2687SS | 2025-10-23 | 2027-06-24 | 436d | 2025-04-07 | 2026-12-07 | 31703d |  |  |  | PP | SI Design | Business & Operation Readiness | 5.0 | Claire Silk | Business & Operational Readiness | 307.33 | Green | GREEN |
| 2730 | 1.9.2 | **Service Activation** |  | 1043d? | 2022-10-31 | 2026-10-28 |  | 2022-10-31 | 2026-10-22 | 289d |  |  | 31874d |  |  | -0 | N/A | N/A | Business & Operation Readiness | 5.24 | N/A |  | -555.67 |  |  |
| 2731 | 1.9.2.1 | **SIT MVC** |  | 770d? | 2022-10-31 | 2025-10-10 |  | 2025-02-03 | 2025-09-22 | 0d |  |  | 32147d |  |  |  |  |  | Business & Operation Readiness | 5.31 |  |  | -650.67 | Overdue Start | RED |
| 2732 | 1.9.2.1.1 | **SIT MVC Service Activation Preparation Tasks** |  | 20d | 2025-02-03 | 2025-02-28 |  | 2025-02-03 | 2025-02-28 | 0d |  |  | 31737d |  |  |  |  |  | Business & Operation Readiness | 5.31 |  |  |  |  |  |
| 2733 | 1.9.2.1.1.1 | Identify operational resources |  | 5d | 2025-02-03 | 2025-02-07 |  | 2025-02-03 | 2025-02-07 | 0d |  |  | 32322d |  | finish no earlier than 2025-02-07 |  |  |  | Business & Operation Readiness | 5.31 |  |  | 45.33 | Green | GREEN |
| 2734 | 1.9.2.1.1.2 | Define and approve operational support model |  | 5d | 2025-02-10 | 2025-02-14 |  | 2025-02-10 | 2025-02-14 | 0d |  |  | 32317d |  | finish no earlier than 2025-02-14 |  |  |  | Business & Operation Readiness | 5.31 |  |  | 52.33 | Green | GREEN |
| 2735 | 1.9.2.1.1.3 | Confirm SA Training completed |  | 10d | 2025-02-10 | 2025-02-21 |  | 2025-02-10 | 2025-02-21 | 0d |  |  | 32312d |  | finish no earlier than 2025-02-21 |  |  |  | Business & Operation Readiness | 5.31 |  |  | 52.33 | Green | GREEN |
| 2736 | 1.9.2.1.1.4 | Participant Engagement / Communications |  | 15d | 2025-02-10 | 2025-02-28 |  | 2025-02-10 | 2025-02-28 | 0d |  |  | 32307d |  | finish no earlier than 2025-02-28 |  |  |  | Business & Operation Readiness | 5.31 |  |  | 52.33 | Green | GREEN |
| 2737 | 1.9.2.1.1.5 | Internal Communications |  | 15d | 2025-02-10 | 2025-02-28 |  | 2025-02-10 | 2025-02-28 | 0d |  |  | 32307d |  | finish no earlier than 2025-02-28 |  |  |  | Business & Operation Readiness | 5.31 |  |  | 52.33 | Green | GREEN |
| 2738 | 1.9.2.1.1.6 | Validate User Access |  | 5d | 2025-02-17 | 2025-02-21 |  | 2025-02-17 | 2025-02-21 | 0d |  |  | 32312d |  | finish no earlier than 2025-02-21 |  |  |  | Business & Operation Readiness | 5.31 |  |  | 59.33 | Green | GREEN |
| 2739 | 1.9.2.1.1.7 | Target Systems and Environments Ready |  | 3d | 2025-02-20 | 2025-02-24 |  | 2025-02-20 | 2025-02-24 | 0d |  |  | 32311d |  | finish no earlier than 2025-02-24 |  | HELIX |  | Business & Operation Readiness | 5.31 |  |  | 62.33 | Green | GREEN |
| 2740 | 1.9.2.1.1.8 | Provide opeartional resources with LWIs |  | 5d | 2025-02-17 | 2025-02-21 |  | 2025-02-17 | 2025-02-21 | 0d |  |  | 32312d |  | finish no earlier than 2025-02-21 |  |  |  | Business & Operation Readiness | 5.31 |  |  | 59.33 | Green | GREEN |
| 2741 | 1.9.2.1.1.9 | Business Readiness Governance Approval |  | 3d | 2025-02-17 | 2025-02-19 |  | 2025-02-17 | 2025-02-19 | 0d |  |  | 32314d |  | finish no earlier than 2025-02-19 |  |  |  | Business & Operation Readiness | 5.31 |  |  | 59.33 | Green | GREEN |
| 2742 | 1.9.2.1.1.10 | SIT MVC Service Activation Preparation Tasks Complete | milestone | 0d | 2025-02-28 | 2025-02-28 |  | 2025-02-28 | 2025-02-28 | 0d |  |  | 31717d | 0d | finish no earlier than 2025-02-28 |  |  |  | Business & Operation Readiness | 5.31 |  |  | 70.71 | Green | GREEN |
| 2743 | 1.9.2.1.2 | MHHSP Confirms SIT MVC PPs MHHS Enabled |  | 1d | 2022-10-31 | 2022-10-31 |  | 2025-04-15 | 2025-04-15 | 0d |  |  | 32326d | 748d |  |  |  |  | Business & Operation Readiness | 5.28 |  |  | -780.67 | Overdue Start | GREEN |
| 2744 | 1.9.2.1.3 | **SIT MVC Service Activation Implementation** |  | 7d? | 2025-09-12 | 2025-09-22 |  | 2025-09-12 | 2025-09-22 | 0d |  |  | 31578d |  |  |  |  |  | Business & Operation Readiness | 6.13 |  |  |  |  |  |
| 2745 | 1.9.2.1.3.1 | Add EFD to DIP |  | 1d | 2025-09-12 | 2025-09-12 | 1974SS, 2743, 2742 | 2025-09-12 | 2025-09-12 | 0d |  |  | 31578d | 0d |  |  |  |  | Business & Operation Readiness | 6.13 |  |  | 266.33 | Green | GREEN |
| 2746 | 1.9.2.1.3.2 | DIP Promoted to Production |  | 1d? | 2025-09-15 | 2025-09-15 | 2745 | 2025-09-15 | 2025-09-15 | 0d |  |  | 31578d | 0d |  |  |  |  | Business & Operation Readiness | 6.13 |  |  | 269.33 | Green | GREEN |
| 2747 | 1.9.2.1.3.3 | SIT LDSOs Create Certificates and Test Connectivity |  | 1d? | 2025-09-16 | 2025-09-16 | 2746 | 2025-09-16 | 2025-09-16 | 0d |  |  | 31578d | 0d |  |  |  |  | Business & Operation Readiness | 6.13 |  |  | 270.33 | Green | GREEN |
| 2748 | 1.9.2.1.3.4 | SIT MVC S&As Create Certificates and Test Connectivity |  | 1d? | 2025-09-16 | 2025-09-16 | 2746 | 2025-09-16 | 2025-09-16 | 0d |  |  | 31600d | 19d |  |  |  |  | Business & Operation Readiness | 6.13 |  |  | 270.33 | Green | GREEN |
| 2749 | 1.9.2.1.3.5 | Create M16 in Customer Solution |  | 2d | 2025-09-16 | 2025-09-17 | 2746 | 2025-09-16 | 2025-09-17 | 0d |  |  | 31578d | 0d | finish no earlier than 2025-03-07 |  |  |  | Business & Operation Readiness | 6.13 |  |  | 270.33 | Green | GREEN |
| 2750 | 1.9.2.1.3.6 | Publish ISD |  | 2d | 2025-09-18 | 2025-09-19 | 2749 | 2025-09-18 | 2025-09-19 | 0d |  |  | 31578d | 0d | finish no earlier than 2025-03-07 |  |  |  | Business & Operation Readiness | 6.13 |  |  | 272.33 | Green | GREEN |
| 2751 | 1.9.2.1.3.7 | SIT LDSOs to update systems with ISD |  | 1d? | 2025-09-22 | 2025-09-22 | 2750 | 2025-09-22 | 2025-09-22 | 0d |  |  | 31582d | 1d |  |  |  |  | Business & Operation Readiness | 6.13 |  |  | 276.33 | Green | GREEN |
| 2752 | 1.9.2.1.3.8 | SIT MVC S&As to update systems with ISD |  | 1d? | 2025-09-22 | 2025-09-22 | 2750 | 2025-09-22 | 2025-09-22 | 0d |  |  | 31596d | 15d |  |  |  |  | Business & Operation Readiness | 6.13 |  |  | 276.33 | Green | GREEN |
| 2753 | 1.9.2.1.3.9 | SIT MVC Service Activation Implementation Complete | milestone | 0d | 2025-09-19 | 2025-09-19 | 2750 | 2025-09-19 | 2025-09-19 | 0d |  |  | 31578d | 0d | finish no earlier than 2025-03-07 |  |  |  | Business & Operation Readiness | 6.13 |  |  | 273.71 | Green | GREEN |

Notes:
- 2728: 10/5 - Detail to be added when available
- 2729: 10/5 - Detail to be added when available
- 2730: 8/7/24 - Likely Servce action will be on a pp by pp basis
- 2743: 22/11/24 - For M11 need MCC enabled - need confirmation suppliers agree to being mhhs enabled
- 2744: 21/11/24 - Dates shifted due to PAB date corrections.
- 2745: 21/11/24 - Dates shifted due to PAB date corrections.
- 2746: 21/11/24 - Dates shifted due to PAB date corrections.
- 2747: 21/11/24 - Dates shifted due to PAB date corrections.
- 2748: 21/11/24 - Dates shifted due to PAB date corrections.
- 2749: 18/09/24 - This milestone is consistent with the Service Activation Verison 2.0 Process Map.

| ID | WBS | Task | Type | Duration | Start | Finish | Predecessors | Baseline start | Baseline finish | Baseline duration | Total slack | Free slack | Constraint | Text9 | Update Version | Task Status | Sched Status | RAG | Involved |
| --- | --- | --- | --- | --- | --- | --- | --- | --- | --- | --- | --- | --- | --- | --- | --- | --- | --- | --- | --- |
| 2754 | 1.9.2.1.4 | **SIT MVC Service Activation Implementation MDD** |  | 15d | 2025-09-22 | 2025-10-10 |  | 2025-03-06 | 2025-03-25 | 0d | 32147d |  |  | Business & Operation Readiness | 6.13 |  |  |  |  |
| 2755 | 1.9.2.1.4.1 | MDD Manual Load |  | 7d | 2025-09-22 | 2025-09-30 | 2750 | 2025-03-06 | 2025-03-14 | 0d | 32147d | 0d | finish no earlier than 2025-03-14 | Business & Operation Readiness | 6.13 | 276.33 | Red | RED |  |
| 2756 | 1.9.2.1.4.2 | MDD Update |  | 8d | 2025-10-01 | 2025-10-10 | 2755 | 2025-03-14 | 2025-03-25 | 0d | 32147d | 0d | finish no earlier than 2025-03-25 | Business & Operation Readiness | 6.13 | 285.33 | Red | RED |  |
| 2757 | 1.9.2.1.4.3 | SIT MVC Service Activation Implementation MDD Complete | milestone | 0d | 2025-10-10 | 2025-10-10 | 2756 | 2025-03-25 | 2025-03-25 | 0d | 32147d |  | finish no earlier than 2025-03-25 | Business & Operation Readiness | 6.13 | 294.71 | Red | RED |  |
| 2758 | 1.9.2.1.5 | **SIT MVC Service Activation Hypercare** |  | 21d | 2025-09-12 | 2025-10-10 |  | 2025-03-03 | 2025-03-26 | 0d | 32147d |  |  | Business & Operation Readiness | 6.13 |  |  |  |  |
| 2759 | 1.9.2.1.5.1 | Service & Process Monitoring |  | 18d | 2025-09-12 | 2025-10-07 | 2745SS | 2025-03-03 | 2025-03-26 | 0d | 32150d |  | finish no earlier than 2025-03-26 | Business & Operation Readiness | 6.13 | 266.33 | Red | RED |  |
| 2760 | 1.9.2.1.5.2 | Daily Reporting |  | 18d | 2025-09-12 | 2025-10-07 | 2745SS | 2025-03-03 | 2025-03-26 | 0d | 32150d |  | finish no earlier than 2025-03-26 | Business & Operation Readiness | 6.13 | 266.33 | Red | RED |  |
| 2761 | 1.9.2.1.5.3 | Issue Management |  | 18d | 2025-09-12 | 2025-10-07 | 2745SS | 2025-03-03 | 2025-03-26 | 0d | 32150d |  | finish no earlier than 2025-03-26 | Business & Operation Readiness | 6.13 | 266.33 | Red | RED |  |
| 2762 | 1.9.2.1.5.4 | SA Hypercare Close Down Activities |  | 18d | 2025-09-12 | 2025-10-07 | 2745SS | 2025-03-03 | 2025-03-26 | 0d | 32147d | 0d | finish no earlier than 2025-03-26 | Business & Operation Readiness | 6.13 | 266.33 | Red | RED |  |
| 2763 | 1.9.2.1.5.5 | Handover to MHHSP |  | 3d | 2025-10-08 | 2025-10-10 | 2762 | 2025-03-21 | 2025-03-25 | 0d | 32147d | 0d | finish no earlier than 2025-03-25 | Business & Operation Readiness | 6.13 | 292.33 | Red | RED | MHHSP |
| 2764 | 1.9.2.1.5.6 | SIT MVC Service Activation Hypercare Complete | milestone | 0d | 2025-10-10 | 2025-10-10 | 2763 | 2025-03-25 | 2025-03-25 | 0d | 32147d |  | finish no earlier than 2025-03-25 | Business & Operation Readiness | 6.13 | 294.71 | Red | RED |  |
| 2765 | 1.9.2.2 | **SIT Non-MVC** |  | 841d? | 2022-10-31 | 2026-01-19 |  | 2022-10-31 | 2026-01-01 | 0d | 32076d |  |  | Business & Operation Readiness | 6.13 | -650.67 | Overdue Start | RED |  |
| 2766 | 1.9.2.2.1 | **SIT Non-MVC Service Activation Preparation Tasks** |  | 610d | 2022-10-31 | 2025-02-28 |  | 2022-10-31 | 2022-10-31 | 0d | 32307d |  |  | Business & Operation Readiness | 6.13 | -651.67 | Overdue Start | RED |  |
| 2767 | 1.9.2.2.1.1 | Helix Preparatory Activities Complete | milestone | 0d | 2025-02-28 | 2025-02-28 | 2742 | 2022-10-31 | 2022-10-31 | 0d | 32307d |  |  | Business & Operation Readiness | 6.13 | 70.71 | Red | RED |  |
| 2768 | 1.9.2.2.1.2 | MHHSP Confirms SIT Non-MVC PPs MHHS Enabled |  | 1d | 2022-10-31 | 2022-10-31 |  | 2022-10-31 | 2022-10-31 | 0d | 32420d | 739d |  | Business & Operation Readiness | 6.13 | -780.67 | Overdue Start | RED |  |
| 2769 | 1.9.2.2.2 | **SIT Non-MVC Service Activation Implementation** |  | 7d? | 2025-12-19 | 2025-12-29 |  | 2025-12-23 | 2026-01-01 | 0d | 31602d |  |  | Business & Operation Readiness | 5.31 |  |  |  |  |
| 2770 | 1.9.2.2.2.1 | Add EDF to DIP |  | 1d | 2025-12-19 | 2025-12-19 | 1980SS, 2768 | 2025-12-23 | 2025-12-24 | 0d | 31602d | 0d | finish no earlier than 2025-06-04 | Business & Operation Readiness | 5.31 | 364.33 | Green | GREEN |  |
| 2771 | 1.9.2.2.2.2 | DIP Promoted to Production |  | 1d | 2025-12-22 | 2025-12-22 | 2770 | 2025-12-25 | 2025-12-26 | 0d | 31602d | 0d | finish no earlier than 2025-06-05 | Business & Operation Readiness | 6.13 | 367.33 | Green | GREEN |  |
| 2772 | 1.9.2.2.2.3 | SIT non-MVC S&As Create Certificates and Test Connectivity |  | 1d? | 2025-12-23 | 2025-12-23 | 2771 |  |  |  | 32095d |  |  | SIT | 6.13 | 368.33 | No BL | GREEN |  |
| 2773 | 1.9.2.2.2.4 | Create M16 in Customer Solution |  | 2d | 2025-12-23 | 2025-12-24 | 2771 | 2025-12-29 | 2025-12-30 | 0d | 31602d | 0d | finish no earlier than 2025-06-06 | Business & Operation Readiness | 6.13 | 368.33 | Green | GREEN |  |
| 2774 | 1.9.2.2.2.5 | Publish ISD |  | 2d | 2025-12-25 | 2025-12-26 | 2773 | 2025-12-31 | 2026-01-01 | 0d | 31602d | 0d | finish no earlier than 2025-06-06 | Business & Operation Readiness | 6.13 | 370.33 | Green | GREEN |  |
| 2775 | 1.9.2.2.2.6 | SIT non-MVC S&As to update systems with ISD |  | 1d? | 2025-12-29 | 2025-12-29 | 2774 |  |  |  | 32091d |  |  | SIT | 6.13 | 374.33 | No BL | GREEN |  |
| 2776 | 1.9.2.2.2.7 | SIT Non-MVC Service Activation Implementation Complete | milestone | 0d | 2025-12-26 | 2025-12-26 | 2774 | 2026-01-01 | 2026-01-01 | 0d | 31602d | 0d | finish no earlier than 2025-06-06 | Business & Operation Readiness | 6.13 | 371.71 | Green | GREEN |  |
| 2777 | 1.9.2.2.3 | **SIT Non-MVC Service Activation Implementation MDD** |  | 15d | 2025-12-29 | 2026-01-16 |  | 2025-06-05 | 2025-06-24 | 0d | 32077d |  |  | Business & Operation Readiness | 6.13 |  |  |  |  |
| 2778 | 1.9.2.2.3.1 | MDD Manual Load |  | 7d | 2025-12-29 | 2026-01-06 | 2774 | 2025-06-05 | 2025-06-13 | 0d | 32077d | 0d | finish no earlier than 2025-06-13 | Business & Operation Readiness | 6.13 | 374.33 | Red | RED |  |
| 2779 | 1.9.2.2.3.2 | MDD Update |  | 8d | 2026-01-07 | 2026-01-16 | 2778 | 2025-06-13 | 2025-06-24 | 0d | 32077d | 0d | finish no earlier than 2025-06-24 | Business & Operation Readiness | 6.13 | 383.33 | Red | RED |  |
| 2780 | 1.9.2.2.3.3 | SIT Non-MVC Service Activation Implementation MDD Complete | milestone | 0d | 2026-01-16 | 2026-01-16 | 2779 | 2025-06-24 | 2025-06-24 | 0d | 32077d |  | finish no earlier than 2025-06-24 | Business & Operation Readiness | 6.13 | 392.71 | Red | RED |  |

Notes:
- 2755: 22/11/24 - Dependency added and date shifted.
- 2756: 22/11/24 - Dependency added and date shifted.
- 2757: 22/11/24 - Dependency added and date shifted.
- 2759: 22/11/24 - Dependency added and date shifted.
- 2760: 22/11/24 - Dependency added and date shifted.
- 2761: 22/11/24 - Dependency added and date shifted.
- 2762: 22/11/24 - Dependency added and date shifted.
- 2763: 22/11/24 - Dependency added and date shifted. / Action: 12/8/24: Why is ths a dep into us?
- 2764: 22/11/24 - Dependency added and date shifted.
- 2765: 22/11/24 - Dependency added and date shifted.
- 2767: Action: 12/8/24: Emailed helix to clarify what needs to go in the prep section and if hypercare is required
- 2768: 22/11/24 - Confirm Predecessors
- 2771: 22/11/24 - Dependency added and date shifted.
- 2772: 22/11/24 - Dependency added and date shifted.
- 2773: 22/11/24 - Dependency added and date shifted.
- 2774: 22/11/24 - Dependency added and date shifted.
- 2775: 22/11/24 - Dependency added and date shifted.
- 2776: 22/11/24 - Dependency added and date shifted.
- 2778: 22/11/24 - Dependency added and date shifted.
- 2779: 22/11/24 - Dependency added and date shifted.
- 2780: 22/11/24 - Dependency added and date shifted.

| ID | WBS | Task | Type | Duration | Start | Finish | Predecessors | Baseline start | Baseline finish | Baseline duration | Total slack | Free slack | Constraint | Text9 | Update Version | Task Status | Sched Status | RAG | Involved |
| --- | --- | --- | --- | --- | --- | --- | --- | --- | --- | --- | --- | --- | --- | --- | --- | --- | --- | --- | --- |
| 2781 | 1.9.2.2.4 | **Non-SIT MVC Service Activation Hypercare** |  | 22d | 2025-12-19 | 2026-01-19 |  | 2025-06-02 | 2025-06-26 | 0d | 32076d |  |  | Business & Operation Readiness | 6.13 |  |  |  |  |
| 2782 | 1.9.2.2.4.1 | Service& Process Monitoring |  | 18d | 2025-12-19 | 2026-01-13 | 2770SS | 2025-06-02 | 2025-06-25 | 0d | 32080d |  | finish no earlier than 2025-06-25 | Business & Operation Readiness | 6.13 | 364.33 | Red | RED |  |
| 2783 | 1.9.2.2.4.2 | Daily Reporting |  | 18d | 2025-12-19 | 2026-01-13 | 2770SS | 2025-06-02 | 2025-06-25 | 0d | 32080d |  | finish no earlier than 2025-06-25 | Business & Operation Readiness | 6.13 | 364.33 | Red | RED |  |
| 2784 | 1.9.2.2.4.3 | Issue Management |  | 18d | 2025-12-19 | 2026-01-13 | 2770SS | 2025-06-02 | 2025-06-25 | 0d | 32080d |  | finish no earlier than 2025-06-25 | Business & Operation Readiness | 6.13 | 364.33 | Red | RED |  |
| 2785 | 1.9.2.2.4.4 | SA Hypercare Close Down Activities |  | 18d | 2025-12-19 | 2026-01-13 | 2770SS | 2025-06-02 | 2025-06-25 | 0d | 32076d | 0d | finish no earlier than 2025-06-25 | Business & Operation Readiness | 6.13 | 364.33 | Red | RED |  |
| 2786 | 1.9.2.2.4.5 | Handover to MHHSP |  | 4d | 2026-01-14 | 2026-01-19 | 2785 | 2025-06-23 | 2025-06-26 | 0d | 32076d | 0d | finish no earlier than 2025-06-26 | Business & Operation Readiness | 6.13 | 390.33 | Red | RED | MHHSP |
| 2787 | 1.9.2.2.4.6 | Non-SIT MVC Service Activation Hypercare Complete (M) | milestone | 0d | 2026-01-19 | 2026-01-19 | 2786 | 2025-06-25 | 2025-06-25 | 0d | 32076d |  | finish no earlier than 2025-06-25 | Business & Operation Readiness | 6.13 | 395.71 | Red | RED |  |
| 2788 | 1.9.2.3 | **Wave 1** |  | 924d | 2022-10-31 | 2026-05-14 |  | 2022-10-31 | 2026-05-14 | 0d | 31993d |  |  | Business & Operation Readiness | 5.31 | -650.67 | Overdue Start | RED |  |
| 2789 | 1.9.2.3.1 | **SIT Non-MVC Service Activation Preparation Tasks** |  | 924d | 2022-10-31 | 2026-05-14 |  | 2022-10-31 | 2026-05-14 | 0d | 31993d |  |  | Business & Operation Readiness | 5.31 | -651.67 | Overdue Start | RED |  |
| 2790 | 1.9.2.3.1.1 | Helix Preparatory Activities Complete | milestone | 0d | 2022-10-31 | 2022-10-31 |  | 2022-10-31 | 2022-10-31 | 0d | 32917d |  |  | Business & Operation Readiness | 5.29 | -780.67 | Overdue Start | RED |  |
| 2791 | 1.9.2.3.1.2 | MHHSP Confirms Wave 1 PPs MHHS Enabled |  | 1d | 2022-10-31 | 2022-10-31 |  | 2022-10-31 | 2022-10-31 | 0d | 32480d | 902d |  | Business & Operation Readiness | 5.28 | -780.67 | Overdue Start | RED |  |
| 2792 | 1.9.2.3.1.3 | Wave 1 Service Activation |  | 21d | 2026-04-16 | 2026-05-14 | 2213, 2791 | 2026-04-13 | 2026-05-14 | 25d | 31578d | 0d |  | Business & Operation Readiness | 6.13 | 482.33 | Green | GREEN |  |
| 2793 | 1.9.2.3.2 | **Wave 1 - Service Activation Implementation** |  | 171d | 2025-09-01 | 2026-04-27 |  | 2025-09-01 | 2025-09-05 | 0d | 32006d |  |  | Business & Operation Readiness | 5.31 |  |  |  |  |
| 2794 | 1.9.2.3.2.1 | MHHSP Enabled Confirmation |  | 2d | 2025-09-01 | 2025-09-02 | 2768 | 2025-09-01 | 2025-09-02 | 0d | 32175d |  | finish no earlier than 2025-09-02 | Business & Operation Readiness | 5.31 | 255.33 | Green | GREEN |  |
| 2795 | 1.9.2.3.2.2 | PAB Approval |  | 2d | 2026-04-16 | 2026-04-17 | 2213 | 2025-09-01 | 2025-09-02 | 0d | 32012d |  | finish no earlier than 2025-09-02 | Business & Operation Readiness | 5.31 | 482.33 | Red | RED |  |
| 2796 | 1.9.2.3.2.3 | Add EFD to DIP |  | 2d | 2026-04-16 | 2026-04-17 | 2213 | 2025-09-02 | 2025-09-03 | 0d | 31995d | 0d | finish no earlier than 2025-09-03 | Business & Operation Readiness | 5.31 | 482.33 | Red | RED |  |
| 2797 | 1.9.2.3.2.4 | DIP Promoted to Production |  | 2d | 2026-04-20 | 2026-04-21 | 2796 | 2025-09-03 | 2025-09-04 | 0d | 31995d | 0d | finish no earlier than 2025-09-04 | Business & Operation Readiness | 5.31 | 486.33 | Red | RED |  |
| 2798 | 1.9.2.3.2.5 | Create M16 in Customer Solution |  | 2d | 2026-04-22 | 2026-04-23 | 2797 | 2025-09-04 | 2025-09-05 | 0d | 31995d | 0d | finish no earlier than 2025-09-05 | Business & Operation Readiness | 5.31 | 488.33 | Red | RED |  |
| 2799 | 1.9.2.3.2.6 | Publish ISD |  | 2d | 2026-04-24 | 2026-04-27 | 2798 | 2025-09-04 | 2025-09-05 | 0d | 31995d | 0d | finish no earlier than 2025-09-05 | Business & Operation Readiness | 5.31 | 490.33 | Red | RED |  |
| 2800 | 1.9.2.3.2.7 | Wave 1 - Service Activation Implementation Complete (M) | milestone | 0d | 2026-04-27 | 2026-04-27 | 2799 | 2025-09-05 | 2025-09-05 | 0d | 32006d |  | finish no earlier than 2025-09-05 | Business & Operation Readiness | 5.31 | 493.71 | Red | RED |  |
| 2801 | 1.9.2.3.3 | **Wave 1 - Service Activation Implementation MDD** |  | 11d | 2026-04-28 | 2026-05-12 |  | 2025-09-04 | 2025-09-17 | 0d | 31995d |  |  | Business & Operation Readiness | 5.31 |  |  |  |  |
| 2802 | 1.9.2.3.3.1 | MDD Manual Load |  | 5d | 2026-04-28 | 2026-05-04 | 2799 | 2025-09-04 | 2025-09-10 | 0d | 31995d | 0d | finish no earlier than 2025-09-10 | Business & Operation Readiness | 5.31 | 494.33 | Red | RED |  |
| 2803 | 1.9.2.3.3.2 | MDD Update |  | 6d | 2026-05-05 | 2026-05-12 | 2802 | 2025-09-10 | 2025-09-17 | 0d | 31995d | 0d | finish no earlier than 2025-09-17 | Business & Operation Readiness | 5.31 | 501.33 | Red | RED |  |
| 2804 | 1.9.2.3.3.3 | Wave 1 - Service Activation Implementation MDD Complete (M) | milestone | 0d | 2026-05-12 | 2026-05-12 | 2803 | 2025-09-17 | 2025-09-17 | 0d | 31995d |  | finish no earlier than 2025-09-17 | Business & Operation Readiness | 5.31 | 508.71 | Red | RED |  |

Notes:
- 2782: 22/11/24 - Dependency added and date shifted.
- 2783: 22/11/24 - Dependency added and date shifted.
- 2784: 22/11/24 - Dependency added and date shifted.
- 2785: 22/11/24 - Dependency added and date shifted.
- 2786: 22/11/24 - Dependency added and date shifted.
- 2787: 22/11/24 - Dependency added and date shifted.
- 2788: 08/07/24 - Confirm Predecessors
- 2790: Action: 12/8/24: Emailed helix to clarify what needs to go in the prep section and if hypercare is required
- 2792: 14/11/24 - Duration reduced to ensure the date remains the same despite a minor change in 2040. Expecting this duration to be further reduced.

| ID | WBS | Task | Type | Duration | Start | Finish | Predecessors | Baseline start | Baseline finish | Baseline duration | Total slack | Free slack | Constraint | Text9 | Update Version | Task Status | Sched Status | RAG | Future RAG |
| --- | --- | --- | --- | --- | --- | --- | --- | --- | --- | --- | --- | --- | --- | --- | --- | --- | --- | --- | --- |
| 2805 | 1.9.2.3.4 | **Wave 1 - Service Activation Hypercare** |  | 177d | 2025-09-01 | 2026-05-05 |  | 2022-10-31 | 2025-09-18 | 0d | 32000d |  |  | Business & Operation Readiness | 5.31 |  |  |  |  |
| 2806 | 1.9.2.3.4.1 | Service& Process Monitoring |  | 14d | 2026-04-16 | 2026-05-05 | 2796SS | 2025-09-01 | 2025-09-18 | 0d | 32000d |  | finish no earlier than 2025-09-18 | Business & Operation Readiness | 5.31 | 482.33 | Red | RED |  |
| 2807 | 1.9.2.3.4.2 | Daily Reporting |  | 14d | 2026-04-16 | 2026-05-05 | 2796SS | 2025-09-01 | 2025-09-18 | 0d | 32000d |  | finish no earlier than 2025-09-18 | Business & Operation Readiness | 5.31 | 482.33 | Red | RED |  |
| 2808 | 1.9.2.3.4.3 | Issue Management |  | 14d | 2026-04-16 | 2026-05-05 | 2796SS | 2025-09-01 | 2025-09-18 | 0d | 32000d |  | finish no earlier than 2025-09-18 | Business & Operation Readiness | 5.31 | 482.33 | Red | RED |  |
| 2809 | 1.9.2.3.4.4 | SA Hypercare Close Down Activities |  | 14d | 2025-09-01 | 2025-09-18 |  | 2025-09-01 | 2025-09-18 | 0d | 32159d | 0d | finish no earlier than 2025-09-18 | Business & Operation Readiness | 5.31 | 255.33 | Green | GREEN |  |
| 2810 | 1.9.2.3.4.5 | Handover to MHHSP |  | 4d | 2025-09-19 | 2025-09-24 | 2809 | 2025-09-15 | 2025-09-18 | 0d | 32159d | 0d | finish no earlier than 2025-09-18 | Business & Operation Readiness | 5.31 | 273.33 | yellow | RED |  |
| 2811 | 1.9.2.3.4.6 | Non-SIT LDSO Service Activation Hypercare Complete (M) | milestone | 0d | 2025-09-24 | 2025-09-24 | 2810 | 2022-10-31 | 2022-10-31 | 0d | 32159d |  |  | Business & Operation Readiness | 5.31 | 278.71 | Red | RED | Dates to be confirmed |
| 2812 | 1.9.2.4 | **Wave 2** |  | 958d | 2022-10-31 | 2026-07-01 |  | 2022-10-31 | 2026-06-30 | 0d | 31959d |  |  | Business & Operation Readiness | 5.31 | -650.67 | Overdue Start | RED |  |
| 2813 | 1.9.2.4.1 | **SIT Non-MVC Service Activation Preparation Tasks** |  | 958d | 2022-10-31 | 2026-07-01 |  | 2022-10-31 | 2026-06-30 | 0d | 31959d |  |  | Business & Operation Readiness | 5.31 | -651.67 | Overdue Start | RED |  |
| 2814 | 1.9.2.4.1.1 | Helix Preparatory Activities Complete | milestone | 0d | 2022-10-31 | 2022-10-31 |  | 2022-10-31 | 2022-10-31 | 0d | 32917d |  |  | Business & Operation Readiness | 5.29 | -780.67 | Overdue Start | RED |  |
| 2815 | 1.9.2.4.1.2 | MHHSP Confirms Wave 2 PPs MHHS Enabled |  | 1d | 2022-10-31 | 2022-10-31 |  | 2022-10-31 | 2022-10-31 | 0d | 32511d | 933d |  | Business & Operation Readiness | 5.28 | -780.67 | Overdue Start | RED |  |
| 2816 | 1.9.2.4.1.3 | Wave 2 Service Activation |  | 24d | 2026-05-29 | 2026-07-01 | 2243, 2815 | 2026-05-28 | 2026-06-30 | 25d | 31578d | 0d |  | Business & Operation Readiness | 5.24 | 525.33 | yellow | RED |  |
| 2817 | 1.9.2.4.2 | **Wave 2 - Service Activation Implementation** |  | 157d | 2025-11-03 | 2026-06-09 |  | 2025-11-03 | 2025-11-07 | 0d | 31975d |  |  | Business & Operation Readiness | 5.31 |  |  |  |  |
| 2818 | 1.9.2.4.2.1 | MHHSP Enabled Confirmation |  | 2d | 2025-11-03 | 2025-11-04 |  | 2025-11-03 | 2025-11-04 | 0d | 32130d |  | finish no earlier than 2025-11-04 | Business & Operation Readiness | 5.31 | 318.33 | Green | GREEN |  |
| 2819 | 1.9.2.4.2.2 | PAB Approval |  | 2d | 2026-05-29 | 2026-06-01 | 2243 | 2025-11-03 | 2025-11-04 | 0d | 31981d |  | finish no earlier than 2025-11-04 | Business & Operation Readiness | 5.31 | 525.33 | Red | RED |  |
| 2820 | 1.9.2.4.2.3 | Add EFD to DIP |  | 2d | 2026-05-29 | 2026-06-01 | 2243 | 2025-11-04 | 2025-11-05 | 0d | 31975d | 0d | finish no earlier than 2025-11-05 | Business & Operation Readiness | 5.31 | 525.33 | Red | RED |  |
| 2821 | 1.9.2.4.2.4 | DIP Promoted to Production |  | 2d | 2026-06-02 | 2026-06-03 | 2820 | 2025-11-05 | 2025-11-06 | 0d | 31975d | 0d | finish no earlier than 2025-11-06 | Business & Operation Readiness | 5.31 | 529.33 | Red | RED |  |
| 2822 | 1.9.2.4.2.5 | Create M16 in Customer Solution |  | 2d | 2026-06-04 | 2026-06-05 | 2821 | 2025-11-06 | 2025-11-07 | 0d | 31975d | 0d | finish no earlier than 2025-11-07 | Business & Operation Readiness | 5.31 | 531.33 | Red | RED |  |
| 2823 | 1.9.2.4.2.6 | Publish ISD |  | 2d | 2026-06-08 | 2026-06-09 | 2822 | 2025-11-06 | 2025-11-07 | 0d | 31975d | 0d | finish no earlier than 2025-11-07 | Business & Operation Readiness | 5.31 | 535.33 | Red | RED |  |
| 2824 | 1.9.2.4.2.7 | Wave 2 - Service Activation Implementation Complete (M) | milestone | 0d | 2026-06-09 | 2026-06-09 | 2823 | 2025-11-07 | 2025-11-07 | 0d | 31975d |  | finish no earlier than 2025-11-07 | Business & Operation Readiness | 5.31 | 536.71 | Red | RED |  |
| 2825 | 1.9.2.4.3 | **Wave 2 - Service Activation Implementation MDD** |  | 10d | 2025-11-06 | 2025-11-19 |  | 2025-11-06 | 2025-11-19 | 0d | 32119d |  |  | Business & Operation Readiness | 5.31 |  |  |  |  |
| 2826 | 1.9.2.4.3.1 | MDD Manual Load |  | 5d | 2025-11-06 | 2025-11-12 |  | 2025-11-06 | 2025-11-12 | 0d | 32124d |  | finish no earlier than 2025-11-12 | Business & Operation Readiness | 5.31 | 321.33 | Green | GREEN |  |
| 2827 | 1.9.2.4.3.2 | MDD Update |  | 6d | 2025-11-12 | 2025-11-19 |  | 2025-11-12 | 2025-11-19 | 0d | 32119d |  | finish no earlier than 2025-11-19 | Business & Operation Readiness | 5.31 | 327.33 | Green | GREEN |  |
| 2828 | 1.9.2.4.3.3 | Wave 2 - Service Activation Implementation MDD Complete (M) | milestone | 0d | 2025-11-19 | 2025-11-19 |  | 2025-11-19 | 2025-11-19 | 0d | 32119d |  | finish no earlier than 2025-11-19 | Business & Operation Readiness | 5.31 | 334.71 | Green | GREEN |  |

Notes:
- 2812: 08/07/24 - Confirm Predecessors
- 2814: Action: 12/8/24: Emailed helix to clarify what needs to go in the prep section and if hypercare is required

| ID | WBS | Task | Type | Duration | Start | Finish | Predecessors | Baseline start | Baseline finish | Baseline duration | Total slack | Free slack | Constraint | Text9 | Update Version | Task Status | Sched Status | RAG | Involved | Future RAG |
| --- | --- | --- | --- | --- | --- | --- | --- | --- | --- | --- | --- | --- | --- | --- | --- | --- | --- | --- | --- | --- |
| 2829 | 1.9.2.4.4 | **Wave 2 - Service Activation Hypercare** |  | 14d | 2025-11-03 | 2025-11-20 |  | 2025-11-03 | 2025-11-20 | 0d | 32118d |  |  | Business & Operation Readiness | 5.31 |  |  |  |  |  |
| 2830 | 1.9.2.4.4.1 | Service& Process Monitoring |  | 14d | 2025-11-03 | 2025-11-20 |  | 2025-11-03 | 2025-11-20 | 0d | 32118d |  | finish no earlier than 2025-11-20 | Business & Operation Readiness | 5.31 | 318.33 | Green | GREEN |  |  |
| 2831 | 1.9.2.4.4.2 | Daily Reporting |  | 14d | 2025-11-03 | 2025-11-20 |  | 2025-11-03 | 2025-11-20 | 0d | 32118d |  | finish no earlier than 2025-11-20 | Business & Operation Readiness | 5.31 | 318.33 | Green | GREEN |  |  |
| 2832 | 1.9.2.4.4.3 | Issue Management |  | 14d | 2025-11-03 | 2025-11-20 |  | 2025-11-03 | 2025-11-20 | 0d | 32118d |  | finish no earlier than 2025-11-20 | Business & Operation Readiness | 5.31 | 318.33 | Green | GREEN |  |  |
| 2833 | 1.9.2.4.4.4 | SA Hypercare Close Down Activities |  | 14d | 2025-11-03 | 2025-11-20 |  | 2025-11-03 | 2025-11-20 | 0d | 32118d |  | finish no earlier than 2025-11-20 | Business & Operation Readiness | 5.31 | 318.33 | Green | GREEN |  |  |
| 2834 | 1.9.2.4.4.5 | Handover to MHHSP |  | 4d | 2025-11-17 | 2025-11-20 |  | 2025-11-17 | 2025-11-20 | 0d | 32118d |  | finish no earlier than 2025-11-20 | Business & Operation Readiness | 5.31 | 332.33 | Green | GREEN | MHHSP |  |
| 2835 | 1.9.2.4.4.6 | Wave 2 - Service Activation Hypercare Complete (M) | milestone | 0d | 2025-11-19 | 2025-11-19 |  | 2025-11-19 | 2025-11-19 | 0d | 32119d |  | finish no earlier than 2025-11-19 | Business & Operation Readiness | 5.31 | 334.71 | Green | GREEN |  |  |
| 2836 | 1.9.2.5 | **Wave 3** |  | 989d | 2022-10-31 | 2026-08-13 |  | 2022-10-31 | 2026-08-26 | 0d | 31928d |  |  | Business & Operation Readiness | 5.31 | -650.67 | Overdue Start | RED |  |  |
| 2837 | 1.9.2.5.1 | **SIT Non-MVC Service Activation Preparation Tasks** |  | 989d | 2022-10-31 | 2026-08-13 |  | 2022-10-31 | 2026-08-26 | 0d | 31928d |  |  | Business & Operation Readiness | 5.31 | -651.67 | Overdue Start | RED |  |  |
| 2838 | 1.9.2.5.1.1 | Helix Preparatory Activities Complete | milestone | 0d | 2022-10-31 | 2022-10-31 |  | 2022-10-31 | 2022-10-31 | 0d | 32917d |  |  | Business & Operation Readiness | 5.29 | -780.67 | Overdue Start | RED |  |  |
| 2839 | 1.9.2.5.1.2 | MHHSP Confirms Wave 3 PPs MHHS Enabled |  | 1d | 2022-10-31 | 2022-10-31 |  | 2022-10-31 | 2022-10-31 | 0d | 32560d | 978d |  | Business & Operation Readiness | 5.28 | -780.67 | Overdue Start | RED |  |  |
| 2840 | 1.9.2.5.1.3 | Wave 3 Service Activation |  | 10d | 2026-07-31 | 2026-08-13 | 2273, 2839 | 2026-07-24 | 2026-08-26 | 25d | 31582d | 0d |  | Business & Operation Readiness | 5.24 | 588.33 | Green | GREEN |  |  |
| 2841 | 1.9.2.5.2 | **Wave 3 - Service Activation Implementation** |  | 169d | 2025-12-22 | 2026-08-13 |  | 2025-12-22 | 2025-12-30 | 0d | 31928d |  |  | Business & Operation Readiness | 5.31 |  |  |  |  |  |
| 2842 | 1.9.2.5.2.1 | MHHSP Enabled Confirmation |  | 2d | 2025-12-22 | 2025-12-23 |  | 2025-12-22 | 2025-12-23 | 0d | 32095d |  | finish no earlier than 2025-12-23 | Business & Operation Readiness | 5.31 | 367.33 | Green | GREEN |  |  |
| 2843 | 1.9.2.5.2.2 | PAB Approval |  | 2d | 2026-07-31 | 2026-08-03 | 2273 | 2025-12-22 | 2025-12-23 | 0d | 31928d | 0d | finish no earlier than 2025-12-23 | Business & Operation Readiness | 5.31 | 588.33 | Red | RED |  |  |
| 2844 | 1.9.2.5.2.3 | Add EFD to DIP |  | 2d | 2026-08-04 | 2026-08-05 | 2273, 2843 | 2025-12-23 | 2025-12-24 | 0d | 31928d | 0d | finish no earlier than 2025-12-24 | Business & Operation Readiness | 5.31 | 592.33 | Red | RED |  |  |
| 2845 | 1.9.2.5.2.4 | DIP Promoted to Production |  | 2d | 2026-08-06 | 2026-08-07 | 2844 | 2025-12-29 | 2025-12-30 | 0d | 31928d | 0d | finish no earlier than 2025-12-30 | Business & Operation Readiness | 5.31 | 594.33 | Red | RED |  |  |
| 2846 | 1.9.2.5.2.5 | Create M16 in Customer Solution |  | 2d | 2026-08-10 | 2026-08-11 | 2845 | 2025-12-29 | 2025-12-30 | 0d | 31928d | 0d | finish no earlier than 2025-12-30 | Business & Operation Readiness | 5.31 | 598.33 | Red | RED |  |  |
| 2847 | 1.9.2.5.2.6 | Publish ISD |  | 2d | 2026-08-12 | 2026-08-13 | 2846 | 2025-12-29 | 2025-12-30 | 0d | 31928d | 0d | finish no earlier than 2025-12-30 | Business & Operation Readiness | 5.31 | 600.33 | Red | RED |  |  |
| 2848 | 1.9.2.5.2.7 | Wave 3 - Service Activation Implementation Complete (M) | milestone | 0d | 2026-08-13 | 2026-08-13 | 2847 | 2025-12-30 | 2025-12-30 | 0d | 31928d |  | finish no earlier than 2025-12-30 | Business & Operation Readiness | 5.31 | 601.71 | Red | RED |  |  |
| 2849 | 1.9.2.5.3 | **Wave 3 - Service Activation Implementation MDD** |  | 839d | 2022-10-31 | 2026-01-15 |  | 2022-10-31 | 2026-01-15 | 0d | 32078d |  |  | Business & Operation Readiness | 5.31 |  |  |  |  |  |
| 2850 | 1.9.2.5.3.1 | MDD Manual Load |  | 7d | 2025-12-29 | 2026-01-06 |  | 2025-12-29 | 2026-01-06 | 0d | 32085d |  | finish no earlier than 2026-01-06 | Business & Operation Readiness | 5.31 | 374.33 | Green | GREEN |  |  |
| 2851 | 1.9.2.5.3.2 | MDD Update |  | 269d | 2025-01-06 | 2026-01-15 |  | 2025-01-06 | 2026-01-15 | 0d | 32078d |  | finish no earlier than 2026-01-15 | Business & Operation Readiness | 5.31 | 17.33 | Green | GREEN |  |  |
| 2852 | 1.9.2.5.3.3 | Wave 3 - Service Activation Implementation MDD Complete (M) | milestone | 0d | 2022-10-31 | 2022-10-31 |  | 2022-10-31 | 2022-10-31 | 0d | 32917d |  |  | Business & Operation Readiness | 5.31 | -780.67 | Overdue Start | RED |  | Dates to be confirmed |

Notes:
- 2837: 08/07/24 - Confirm Predecessors
- 2838: Action: 12/8/24: Emailed helix to clarify what needs to go in the prep section and if hypercare is required

| ID | WBS | Task | Type | Duration | Start | Finish | Predecessors | Baseline start | Baseline finish | Baseline duration | Total slack | Free slack | Constraint | Text9 | Update Version | Task Status | Sched Status | RAG | Involved | Future RAG |
| --- | --- | --- | --- | --- | --- | --- | --- | --- | --- | --- | --- | --- | --- | --- | --- | --- | --- | --- | --- | --- |
| 2853 | 1.9.2.5.4 | **Wave 3 - Service Activation Hypercare** |  | 840d | 2022-10-31 | 2026-01-16 |  | 2022-10-31 | 2026-01-16 | 0d | 32077d |  |  | Business & Operation Readiness | 5.31 |  |  |  |  |  |
| 2854 | 1.9.2.5.4.1 | Service& Process Monitoring |  | 20d | 2025-12-22 | 2026-01-16 |  | 2025-12-22 | 2026-01-16 | 0d | 32077d |  | finish no earlier than 2026-01-16 | Business & Operation Readiness | 5.31 | 367.33 | Green | GREEN |  |  |
| 2855 | 1.9.2.5.4.2 | Daily Reporting |  | 20d | 2025-12-22 | 2026-01-16 |  | 2025-12-22 | 2026-01-16 | 0d | 32077d |  | finish no earlier than 2026-01-16 | Business & Operation Readiness | 5.31 | 367.33 | Green | GREEN |  |  |
| 2856 | 1.9.2.5.4.3 | Issue Management |  | 20d | 2025-12-22 | 2026-01-16 |  | 2025-12-22 | 2026-01-16 | 0d | 32077d |  | finish no earlier than 2026-01-16 | Business & Operation Readiness | 5.31 | 367.33 | Green | GREEN |  |  |
| 2857 | 1.9.2.5.4.4 | SA Hypercare Close Down Activities |  | 20d | 2025-12-22 | 2026-01-16 |  | 2025-12-22 | 2026-01-16 | 0d | 32077d |  | finish no earlier than 2026-01-16 | Business & Operation Readiness | 5.31 | 367.33 | Green | GREEN |  |  |
| 2858 | 1.9.2.5.4.5 | Handover to MHHSP |  | 4d | 2026-01-12 | 2026-01-15 |  | 2026-01-12 | 2026-01-15 | 0d | 32078d |  | finish no earlier than 2026-01-15 | Business & Operation Readiness | 5.31 | 388.33 | Green | GREEN | MHHSP |  |
| 2859 | 1.9.2.5.4.6 | Wave 3 Service Activation Hypercare Complete (M) | milestone | 0d | 2022-10-31 | 2022-10-31 |  | 2022-10-31 | 2022-10-31 | 0d | 32917d |  |  | Business & Operation Readiness | 5.31 | -780.67 | Overdue Start | RED |  | Date to be confirmed |
| 2860 | 1.9.2.6 | **Wave 4** |  | 1043d | 2022-10-31 | 2026-10-28 |  | 2022-10-31 | 2026-10-22 | 0d | 31874d |  |  | Business & Operation Readiness | 5.31 | -650.67 | Overdue Start | RED |  |  |
| 2861 | 1.9.2.6.1 | **SIT Non-MVC Service Activation Preparation Tasks** |  | 1043d | 2022-10-31 | 2026-10-28 |  | 2022-10-31 | 2026-10-22 | 0d | 31874d |  |  | Business & Operation Readiness | 5.31 | -651.67 | Overdue Start | RED |  |  |
| 2862 | 1.9.2.6.1.1 | Helix Preparatory Activities Complete | milestone | 0d | 2022-10-31 | 2022-10-31 |  | 2022-10-31 | 2022-10-31 | 0d | 32917d |  |  | Business & Operation Readiness | 5.29 | -780.67 | Overdue Start | RED |  |  |
| 2863 | 1.9.2.6.1.2 | MHHSP Confirms Wave 4 PPs MHHS Enabled |  | 1d | 2022-10-31 | 2022-10-31 |  | 2022-10-31 | 2022-10-31 | 0d | 32591d | 1018d |  | Business & Operation Readiness | 5.28 | -780.67 | Overdue Start | RED |  |  |
| 2864 | 1.9.2.6.1.3 | Wave 4 Service Activation |  | 24d | 2026-09-25 | 2026-10-28 | 2303, 2863 | 2026-09-21 | 2026-10-22 | 25d | 31573d | 0d |  | Business & Operation Readiness | 5.24 | 644.33 | yellow | RED |  |  |
| 2865 | 1.9.2.6.2 | **Wave 4 - Service Activation Implementation** |  | 158d | 2026-03-02 | 2026-10-07 |  | 2025-03-03 | 2026-03-06 | 0d | 31889d |  |  | Business & Operation Readiness | 5.31 |  |  |  |  |  |
| 2866 | 1.9.2.6.2.1 | MHHSP Enabled Confirmation |  | 2d | 2026-03-02 | 2026-03-03 |  | 2026-03-02 | 2026-03-03 | 0d | 32045d |  | finish no earlier than 2026-03-03 | Business & Operation Readiness | 5.31 | 437.33 | Green | GREEN |  |  |
| 2867 | 1.9.2.6.2.2 | PAB Approval |  | 1d | 2026-09-25 | 2026-09-25 | 2303 | 2025-03-03 | 2025-03-03 | 0d | 31889d | 0d | finish no earlier than 2025-03-03 | Business & Operation Readiness | 5.31 | 644.33 | Red | RED |  |  |
| 2868 | 1.9.2.6.2.3 | Add EFD to DIP |  | 2d | 2026-09-28 | 2026-09-29 | 2867 | 2026-03-03 | 2026-03-04 | 0d | 31889d | 0d | finish no earlier than 2026-03-04 | Business & Operation Readiness | 5.31 | 647.33 | Red | RED |  |  |
| 2869 | 1.9.2.6.2.4 | DIP Promoted to Production |  | 2d | 2026-09-30 | 2026-10-01 | 2868 | 2026-03-04 | 2026-03-05 | 0d | 31889d | 0d | finish no earlier than 2026-03-05 | Business & Operation Readiness | 5.31 | 649.33 | Red | RED |  |  |
| 2870 | 1.9.2.6.2.5 | Create M16 in Customer Solution |  | 2d | 2026-10-02 | 2026-10-05 | 2869 | 2026-03-05 | 2026-03-06 | 0d | 31889d | 0d | finish no earlier than 2026-03-06 | Business & Operation Readiness | 5.31 | 651.33 | Red | RED |  |  |
| 2871 | 1.9.2.6.2.6 | Publish ISD |  | 2d | 2026-10-06 | 2026-10-07 | 2870 | 2026-03-05 | 2026-03-06 | 0d | 31889d | 0d | finish no earlier than 2026-03-06 | Business & Operation Readiness | 5.31 | 655.33 | Red | RED |  |  |
| 2872 | 1.9.2.6.2.7 | Wave 4 - Service Activation Implementation Complete (M) | milestone | 0d | 2026-10-07 | 2026-10-07 | 2871 | 2026-03-06 | 2026-03-06 | 0d | 31889d |  | finish no earlier than 2026-03-06 | Business & Operation Readiness | 5.31 | 656.71 | Red | RED |  |  |
| 2873 | 1.9.2.6.3 | **Wave 4 - Service Activation Implementation MDD** |  | 15d | 2026-03-06 | 2026-03-26 |  | 2026-03-06 | 2026-03-26 | 0d | 32028d |  |  | Business & Operation Readiness | 5.31 |  |  |  |  |  |
| 2874 | 1.9.2.6.3.1 | MDD Manual Load |  | 7d | 2026-03-06 | 2026-03-16 |  | 2026-03-06 | 2026-03-16 | 0d | 32036d |  | finish no earlier than 2026-03-16 | Business & Operation Readiness | 5.31 | 441.33 | Green | GREEN |  |  |
| 2875 | 1.9.2.6.3.2 | MDD Update |  | 9d | 2026-03-16 | 2026-03-26 |  | 2026-03-16 | 2026-03-26 | 0d | 32028d |  | finish no earlier than 2026-03-26 | Business & Operation Readiness | 5.31 | 451.33 | Green | GREEN |  |  |
| 2876 | 1.9.2.6.3.3 | Wave 4 - Service Activation Implementation MDD Complete | milestone | 0d | 2026-03-25 | 2026-03-25 |  | 2026-03-25 | 2026-03-25 | 0d | 32029d |  | finish no earlier than 2026-03-25 | Business & Operation Readiness | 5.31 | 460.71 | Green | GREEN |  |  |

Notes:
- 2860: 08/07/24 - Confirm Predecessors
- 2862: Action: 12/8/24: Emailed helix to clarify what needs to go in the prep section and if hypercare is required
- 2863: 8/7/24 - Confirm Predecessors

| ID | WBS | Task | Type | Duration | Start | Finish | Predecessors | Baseline start | Baseline finish | Baseline duration | Total slack | Free slack | Constraint | Text9 | Update Version | Task Status | Sched Status | RAG | Involved | Responsible |
| --- | --- | --- | --- | --- | --- | --- | --- | --- | --- | --- | --- | --- | --- | --- | --- | --- | --- | --- | --- | --- |
| 2877 | 1.9.2.6.4 | **Wave 4 - Service Activation Hypercare** |  | 19d | 2026-03-02 | 2026-03-26 |  | 2026-03-02 | 2026-03-26 | 0d | 32028d |  |  | Business & Operation Readiness | 5.31 |  |  |  |  |  |
| 2878 | 1.9.2.6.4.1 | Service& Process Monitoring |  | 19d | 2026-03-02 | 2026-03-26 |  | 2026-03-02 | 2026-03-26 | 0d | 32028d |  | finish no earlier than 2026-03-26 | Business & Operation Readiness | 5.31 | 437.33 | Green | GREEN |  |  |
| 2879 | 1.9.2.6.4.2 | Daily Reporting |  | 19d | 2026-03-02 | 2026-03-26 |  | 2026-03-02 | 2026-03-26 | 0d | 32028d |  | finish no earlier than 2026-03-26 | Business & Operation Readiness | 5.31 | 437.33 | Green | GREEN |  |  |
| 2880 | 1.9.2.6.4.3 | Issue Management |  | 19d | 2026-03-02 | 2026-03-26 |  | 2026-03-02 | 2026-03-26 | 0d | 32028d |  | finish no earlier than 2026-03-26 | Business & Operation Readiness | 5.31 | 437.33 | Green | GREEN |  |  |
| 2881 | 1.9.2.6.4.4 | SA Hypercare Close Down Activities |  | 19d | 2026-03-02 | 2026-03-26 |  | 2026-03-02 | 2026-03-26 | 0d | 32028d |  | finish no earlier than 2026-03-26 | Business & Operation Readiness | 5.31 | 437.33 | Green | GREEN |  |  |
| 2882 | 1.9.2.6.4.5 | Handover to MHHSP |  | 4d | 2026-03-02 | 2026-03-05 |  | 2026-03-02 | 2026-03-05 | 0d | 32043d |  | finish no earlier than 2026-03-05 | Business & Operation Readiness | 5.31 | 437.33 | Green | GREEN | MHHSP |  |
| 2883 | 1.9.2.6.4.6 | Wave 4 - Service Activation Hypercare Complete (M) | milestone | 0d | 2026-03-25 | 2026-03-25 |  | 2026-03-25 | 2026-03-25 | 0d | 32029d |  | finish no earlier than 2026-03-25 | Business & Operation Readiness | 5.31 | 460.71 | Green | GREEN |  |  |
| 2884 | 1.9.2.7 | **Non-SIT LDSO** |  | 754d | 2022-10-31 | 2025-09-18 |  | 2022-10-31 | 2025-09-01 | 0d | 32163d |  |  | Business & Operation Readiness | 5.31 | -650.67 | Overdue Start | RED |  |  |
| 2885 | 1.9.2.7.1 | **Non-SIT LDSO Service Activation Data Loading** |  | 176d | 2024-06-07 | 2025-02-07 |  | 2024-06-07 | 2025-02-07 | 0d | 32322d |  |  | Business & Operation Readiness | 5.31 |  |  |  |  |  |
| 2886 | 1.9.2.7.1.1 | Define pre Non-SIT LDSO upfront activities |  | 7d | 2024-06-07 | 2024-06-17 |  | 2024-06-07 | 2024-06-17 | 0d | 32491d |  | finish no earlier than 2024-06-17 | Business & Operation Readiness | 5.31 | -195.67 | Overdue Start | RED |  |  |
| 2887 | 1.9.2.7.1.2 | **Execute Non-SIT LDSO Activities** |  | 5d | 2025-02-03 | 2025-02-07 |  | 2025-02-03 | 2025-02-07 | 0d | 32322d |  |  | Business & Operation Readiness | 5.31 |  |  |  |  |  |
| 2888 | 1.9.2.7.1.2.1 | Create Entity Forms in Customer Solution |  | 3d | 2025-02-03 | 2025-02-05 |  | 2025-02-03 | 2025-02-05 | 0d | 32324d |  | finish no earlier than 2025-02-05 | Business & Operation Readiness | 5.31 | 45.33 | Green | GREEN |  | PMP |
| 2889 | 1.9.2.7.1.2.2 | DIP - Promote to Production Environment |  | 3d | 2025-02-03 | 2025-02-05 |  | 2025-02-03 | 2025-02-05 | 0d | 32324d |  | finish no earlier than 2025-02-05 | Business & Operation Readiness | 5.31 | 45.33 | Green | GREEN |  | DIP |
| 2890 | 1.9.2.7.1.2.3 | DIP - Enable Technology capabilities for participants |  | 3d | 2025-02-03 | 2025-02-05 |  | 2025-02-03 | 2025-02-05 | 0d | 32324d |  | finish no earlier than 2025-02-05 | Business & Operation Readiness | 5.31 | 45.33 | Green | GREEN |  | DIP |
| 2891 | 1.9.2.7.1.2.4 | DIP - Add EFD to DIP |  | 3d | 2025-02-03 | 2025-02-05 |  | 2025-02-03 | 2025-02-05 | 0d | 32324d |  | finish no earlier than 2025-02-05 | Business & Operation Readiness | 5.31 | 45.33 | Green | GREEN |  | DIP |
| 2892 | 1.9.2.7.1.2.5 | ISD - Replicate Entity Forms from CS |  | 2d | 2025-02-06 | 2025-02-07 |  | 2025-02-06 | 2025-02-07 | 0d | 32322d |  | finish no earlier than 2025-02-07 | Business & Operation Readiness | 5.31 | 48.33 | Green | GREEN |  | HELIX |
| 2893 | 1.9.2.7.1.2.6 | MDD - Load MHHS roles |  | 3d | 2025-02-03 | 2025-02-05 |  | 2025-02-03 | 2025-02-05 | 0d | 32324d |  | finish no earlier than 2025-02-05 | Business & Operation Readiness | 5.31 | 45.33 | Green | GREEN |  | PMP |
| 2894 | 1.9.2.7.1.3 | Non-SIT LDSO Service Activation Data Loading Completed (M) | milestone | 0d | 2025-02-07 | 2025-02-07 |  | 2025-02-07 | 2025-02-07 | 0d | 32322d |  | finish no earlier than 2025-02-07 | Business & Operation Readiness | 5.31 | 49.71 | Green | GREEN |  |  |
| 2895 | 1.9.2.7.2 | **SIT Non-MVC Service Activation Preparation Tasks** |  | 754d | 2022-10-31 | 2025-09-18 |  | 2022-10-31 | 2025-09-01 | 0d | 32163d |  |  | Business & Operation Readiness | 5.31 | -651.67 | Overdue Start | RED |  |  |
| 2896 | 1.9.2.7.2.1 | Helix Preparatory Activities Complete | milestone | 0d | 2022-10-31 | 2022-10-31 |  | 2022-10-31 | 2022-10-31 | 0d | 32917d |  |  | Business & Operation Readiness | 5.29 | -780.67 | Overdue Start | RED |  |  |
| 2897 | 1.9.2.7.2.2 | MHHSP Confirms Non-SIT LDSO PPs MHHS Enabled |  | 1d | 2022-10-31 | 2022-10-31 |  | 2022-10-31 | 2022-10-31 | 0d | 32329d | 747d |  | Business & Operation Readiness | 5.28 | -780.67 | Overdue Start | RED |  |  |
| 2898 | 1.9.2.7.2.3 | Non-SIT LDSO Service Activation |  | 6d | 2025-09-11 | 2025-09-18 | 2897, 1992 | 2025-08-25 | 2025-09-01 | 9d | 31582d | 4d |  | Business & Operation Readiness | 6.12 | 265.33 | Red | RED |  |  |
| 2899 | 1.9.2.7.3 | **Non-SIT LDSO Service Activation Implementation** |  | 4d | 2025-02-24 | 2025-02-27 |  | 2025-02-24 | 2025-02-27 | 0d | 32308d |  |  | Business & Operation Readiness | 5.31 |  |  |  |  |  |
| 2900 | 1.9.2.7.3.1 | MHHSP Enabled Confirmation |  | 2d | 2025-02-24 | 2025-02-25 |  | 2025-02-24 | 2025-02-25 | 0d | 32310d |  | finish no earlier than 2025-02-25 | Business & Operation Readiness | 5.31 | 66.33 | Green | GREEN |  | MHHSP |
| 2901 | 1.9.2.7.3.2 | PAB Approval |  | 2d | 2025-02-24 | 2025-02-25 |  | 2025-02-24 | 2025-02-25 | 0d | 32310d |  | finish no earlier than 2025-02-25 | Business & Operation Readiness | 5.31 | 66.33 | Green | GREEN |  | QUALF |
| 2902 | 1.9.2.7.3.3 | Add EFD to DIP |  | 2d | 2025-02-25 | 2025-02-26 |  | 2025-02-25 | 2025-02-26 | 0d | 32309d |  | finish no earlier than 2025-02-26 | Business & Operation Readiness | 5.31 | 67.33 | Green | GREEN |  | DIP |
| 2903 | 1.9.2.7.3.4 | DIP Promoted to Production |  | 2d | 2025-02-26 | 2025-02-27 |  | 2025-02-26 | 2025-02-27 | 0d | 32308d |  | finish no earlier than 2025-02-27 | Business & Operation Readiness | 5.31 | 68.33 | Green | GREEN |  | DIP |
| 2904 | 1.9.2.7.3.5 | Create M16 in Customer Solution |  | 2d | 2025-02-26 | 2025-02-27 |  | 2025-02-26 | 2025-02-27 | 0d | 32308d |  | finish no earlier than 2025-02-27 | Business & Operation Readiness | 5.31 | 68.33 | Green | GREEN |  | PMP |
| 2905 | 1.9.2.7.3.6 | Publish ISD |  | 2d | 2025-02-26 | 2025-02-27 |  | 2025-02-26 | 2025-02-27 | 0d | 32308d |  | finish no earlier than 2025-02-27 | Business & Operation Readiness | 5.31 | 68.33 | Green | GREEN |  |  |
| 2906 | 1.9.2.7.3.7 | Non-SIT LDSO Service Activation Implementation Completed (M) | milestone | 0d | 2025-02-27 | 2025-02-27 |  | 2025-02-27 | 2025-02-27 | 0d | 32308d |  | finish no earlier than 2025-02-27 | Business & Operation Readiness | 5.31 | 69.71 | Green | GREEN |  |  |

Notes:
- 2896: Action: 12/8/24: Emailed helix to clarify what needs to go in the prep section and if hypercare is required
- 2897: 08/07/24 - Confirm Predecessors
- 2898: 13/11/24 - Dependency updated so that this activity is now connected to the right activity. This has resulted in the forecast slipping, but this is now the correct date, this will be baselined at Approval Group.

| ID | WBS | Task | Type | Duration | Start | Finish | Predecessors | Baseline start | Baseline finish | Baseline duration | Baseline 1 start | Baseline 1 finish | Total slack | Free slack | Constraint | Baseline cost | Text9 | Update Version | Responsible | Task Status | Sched Status | RAG | Involved | MHHS Resource Name | MHHS Programme Phase | Artefact ID | Action |
| --- | --- | --- | --- | --- | --- | --- | --- | --- | --- | --- | --- | --- | --- | --- | --- | --- | --- | --- | --- | --- | --- | --- | --- | --- | --- | --- | --- |
| 2907 | 1.9.2.7.4 | **Non-SIT LDSO Service Activation Implementation MDD** |  | 14d | 2025-02-27 | 2025-03-18 |  | 2025-02-27 | 2025-03-18 | 0d |  |  | 32295d |  |  |  | Business & Operation Readiness | 5.31 |  |  |  |  |  |  |  |  |  |
| 2908 | 1.9.2.7.4.1 | MDD Manual Load |  | 7d | 2025-02-27 | 2025-03-07 |  | 2025-02-27 | 2025-03-07 | 0d |  |  | 32302d |  | finish no earlier than 2025-03-07 |  | Business & Operation Readiness | 5.31 | PMP | 69.33 | Green | GREEN |  |  |  |  |  |
| 2909 | 1.9.2.7.4.2 | MDD Update |  | 8d | 2025-03-07 | 2025-03-18 |  | 2025-03-07 | 2025-03-18 | 0d |  |  | 32295d |  | finish no earlier than 2025-03-18 |  | Business & Operation Readiness | 5.31 | PMP | 77.33 | Green | GREEN |  |  |  |  |  |
| 2910 | 1.9.2.7.4.3 | Non-SIT LDSO Service Activation Implementation MDD Complete (M) | milestone | 0d | 2025-03-18 | 2025-03-18 |  | 2025-03-18 | 2025-03-18 | 0d |  |  | 32295d |  | finish no earlier than 2025-03-18 |  | Business & Operation Readiness | 5.31 |  | 88.71 | Green | GREEN |  |  |  |  |  |
| 2911 | 1.9.2.7.5 | **Non-SIT LDSO Service Activation Hypercare** |  | 18d | 2025-02-24 | 2025-03-19 |  | 2025-02-24 | 2025-03-19 | 0d |  |  | 32294d |  |  |  | Business & Operation Readiness | 5.31 |  |  |  |  |  |  |  |  |  |
| 2912 | 1.9.2.7.5.1 | **Non-SIT LDSO Service Activation Hypercare Support** |  | 18d | 2025-02-24 | 2025-03-19 |  | 2025-02-24 | 2025-03-19 | 0d |  |  | 32294d |  |  |  | Business & Operation Readiness | 5.31 |  |  |  |  |  |  |  |  |  |
| 2913 | 1.9.2.7.5.1.1 | Service& Process Monitoring |  | 18d | 2025-02-24 | 2025-03-19 |  | 2025-02-24 | 2025-03-19 | 0d |  |  | 32294d |  | finish no earlier than 2025-03-19 |  | Business & Operation Readiness | 5.31 |  | 66.33 | Green | GREEN |  |  |  |  |  |
| 2914 | 1.9.2.7.5.1.2 | Daily Reporting |  | 18d | 2025-02-24 | 2025-03-19 |  | 2025-02-24 | 2025-03-19 | 0d |  |  | 32294d |  | finish no earlier than 2025-03-19 |  | Business & Operation Readiness | 5.31 |  | 66.33 | Green | GREEN |  |  |  |  |  |
| 2915 | 1.9.2.7.5.1.3 | Issue Management |  | 18d | 2025-02-24 | 2025-03-19 |  | 2025-02-24 | 2025-03-19 | 0d |  |  | 32294d |  | finish no earlier than 2025-03-19 |  | Business & Operation Readiness | 5.31 |  | 66.33 | Green | GREEN |  |  |  |  |  |
| 2916 | 1.9.2.7.5.1.4 | SA Hypercare Close Down Activities |  | 18d | 2025-02-24 | 2025-03-19 |  | 2025-02-24 | 2025-03-19 | 0d |  |  | 32294d |  | finish no earlier than 2025-03-19 |  | Business & Operation Readiness | 5.31 |  | 66.33 | Green | GREEN |  |  |  |  |  |
| 2917 | 1.9.2.7.5.1.5 | Handover to MHHSP |  | 3d | 2025-03-14 | 2025-03-18 |  | 2025-03-14 | 2025-03-18 | 0d |  |  | 32295d |  | finish no earlier than 2025-03-18 |  | Business & Operation Readiness | 5.31 |  | 84.33 | Green | GREEN | MHHSP |  |  |  |  |
| 2918 | 1.9.2.7.5.1.6 | Non-SIT LDSO Service Activation Hypercare Complete (M) | milestone | 0d | 2025-03-18 | 2025-03-18 |  | 2025-03-18 | 2025-03-18 | 0d |  |  | 32295d |  | finish no earlier than 2025-03-18 |  | Business & Operation Readiness | 5.31 |  | 88.71 | Green | GREEN |  |  |  |  |  |
| 2919 | 1.9.3 | **Implement Early Life Support Plan** |  | 55d | 2025-07-07 | 2025-09-19 |  | 2025-07-07 | 2025-09-19 | 45d | 2025-01-06 | 2025-02-28 | 32162d |  |  | -0 | Business & Operation Readiness | 5.0 | N/A |  |  |  | N/A | N/A | Business & Operational Readiness |  |  |
| 2920 | 1.9.3.1 | Implement Early Life Support Plan |  | 55d | 2025-07-07 | 2025-09-19 |  | 2025-07-07 | 2025-09-19 | 45d | 2025-02-28 | 2025-02-28 | 32162d |  | start no earlier than 2025-07-07 |  | Business & Operation Readiness | 5.23 | SI Transition | 199.33 | Green | GREEN | SI Transition,CPT | Matthew Breen | Business & Operational Readiness | MHHS-ART095 |  |
| 2921 | 1.9.4 | **Business Continuity and Disaster Recovery Plan** |  | 40d | 2025-07-31 | 2025-09-24 |  | 2025-07-31 | 2025-09-24 | 40d | 2025-01-13 | 2025-03-07 | 32159d |  |  |  | Business & Operation Readiness | 5.0 | N/A |  |  |  | N/A | N/A | Business & Operational Readiness |  |  |
| 2922 | 1.9.4.1 | Central Parties BCDRs in Place |  | 20d | 2025-07-31 | 2025-08-27 | 2440FS-40d | 2025-07-31 | 2025-08-27 | 20d | 2025-01-13 | 2025-02-07 | 32159d | 0d |  |  | Business & Operation Readiness | 5.0 | SI Design | 223.33 | Green | GREEN |  | MHHS Programme | Business & Operational Readiness |  |  |
| 2923 | 1.9.4.2 | Risk Based Assurance of Cental Party BCDRs |  | 20d | 2025-08-28 | 2025-09-24 | 2922 | 2025-08-28 | 2025-09-24 | 20d | 2025-02-10 | 2025-03-07 | 32159d |  |  |  | Business & Operation Readiness | 5.0 | PP | 251.33 | Green | GREEN | SI Design | MHHS Programme | Business & Operational Readiness |  |  |
| 2924 | 1.9.5 | **Training and Support Materials** |  | 39d | 2025-08-21 | 2025-10-14 |  | 2025-08-21 | 2025-10-14 | 40d | 2025-02-03 | 2025-03-28 | 32145d |  |  |  | Business & Operation Readiness | 5.0 | N/A |  |  |  | N/A | N/A | Business & Operational Readiness |  | 10/5: To be reworked with better clarity (LH) |
| 2925 | 1.9.5.1 | Develop document |  | 20d | 2025-08-21 | 2025-09-17 | 2711FS-45d | 2025-08-21 | 2025-09-17 | 20d | 2025-02-03 | 2025-02-28 | 32145d | 0d |  |  | Business & Operation Readiness | 5.0 | SI Migration | 244.33 | Green | GREEN | CPT | PPC | Business & Operational Readiness |  |  |
| 2926 | 1.9.5.2 | Document review and update |  | 19d | 2025-09-18 | 2025-10-14 | 2925 | 2025-09-18 | 2025-10-14 | 20d | 2025-03-03 | 2025-03-28 | 32145d | 0d |  |  | Business & Operation Readiness | 5.0 | SI Migration | 272.33 | Green | GREEN | PMO,CPT,IPA,PP | PPC | Business & Operational Readiness |  |  |
| 2927 | 1.9.5.3 | Training and Support Materials approved | milestone | 0d | 2025-10-14 | 2025-10-14 | 2926 | 2025-10-14 | 2025-10-14 | 0d | 2025-03-28 | 2025-03-28 | 32145d |  |  |  | Business & Operation Readiness | 5.0 | SI Migration | 298.71 | Green | GREEN | PMO,CPT | PPC | Business & Operational Readiness | MHHS-ART118 |  |
| 2928 | 1.9.6 | **PP Business Change** |  | 129d | 2025-02-03 | 2025-07-31 |  | 2025-02-03 | 2025-07-31 | 129d | 2025-02-03 | 2025-07-31 | 32198d |  |  |  | Business & Operation Readiness | 5.0 | N/A | M11 |  |  | N/A | N/A | Business & Operational Readiness |  | 10/5: Review with PPC (LH) |
| 2929 | 1.9.6.1 | Plan stakeholder management |  | 129d | 2025-02-03 | 2025-07-31 |  | 2025-02-03 | 2025-07-31 | 129d | 2025-02-03 | 2025-07-31 | 32198d |  | start no earlier than 2025-02-03 |  | Business & Operation Readiness | 5.0 | PP | 45.33 | Green | GREEN | PPC | PPC | Business & Operational Readiness |  |  |
| 2930 | 1.9.6.2 | Manage stakeholders |  | 129d | 2025-02-03 | 2025-07-31 |  | 2025-02-03 | 2025-07-31 | 129d | 2025-02-03 | 2025-07-31 | 32198d |  | start no earlier than 2025-02-03 |  | Business & Operation Readiness | 5.0 | PP | 45.33 | Green | GREEN | PPC | PPC | Business & Operational Readiness |  |  |
| 2931 | 1.9.6.3 | Develop & implement changes to KPIs, organisation & people management |  | 129d | 2025-02-03 | 2025-07-31 |  | 2025-02-03 | 2025-07-31 | 129d | 2025-02-03 | 2025-07-31 | 32198d |  | start no earlier than 2025-02-03 |  | Business & Operation Readiness | 5.0 | PP | 45.33 | Green | GREEN | PPC | PPC | Business & Operational Readiness |  |  |
| 2932 | 1.9.6.4 | Develop & test changes to business processes |  | 129d | 2025-02-03 | 2025-07-31 |  | 2025-02-03 | 2025-07-31 | 129d | 2025-02-03 | 2025-07-31 | 32198d |  | start no earlier than 2025-02-03 |  | Business & Operation Readiness | 5.0 | PP | 45.33 | Green | GREEN | PPC | PPC | Business & Operational Readiness |  |  |
| 2933 | 1.9.6.5 | Develop and deliver training |  | 129d | 2025-02-03 | 2025-07-31 |  | 2025-02-03 | 2025-07-31 | 129d | 2025-02-03 | 2025-07-31 | 32198d |  | start no earlier than 2025-02-03 |  | Business & Operation Readiness | 5.0 | PP | 45.33 | Green | GREEN | PPC | PPC | Business & Operational Readiness |  |  |
| 2934 | 1.9.6.6 | Programme support for PP Business Change activities |  | 129d | 2025-02-03 | 2025-07-31 |  | 2025-02-03 | 2025-07-31 | 129d | 2025-02-03 | 2025-07-31 | 32198d |  | start no earlier than 2025-02-03 |  | Business & Operation Readiness | 5.0 | PPC | 45.33 | Green | GREEN | PP | PPC | Business & Operational Readiness |  |  |

Notes:
- 2920: 12/11/24 - Once MCAG approval of Early Life Support Plan is secured, dependency will be added back in.

| ID | WBS | Task | Type | Duration | Start | Finish | Predecessors | Baseline start | Baseline finish | Baseline duration | Baseline 1 start | Baseline 1 finish | Total slack | Free slack | Baseline cost | Responsible | Involved | Text9 | Task Status | Update Version | MHHS Resource Name | MHHS Programme Phase | Sched Status | RAG | Milestone ID | Text29 | Tier | Future RAG | Artefact ID |
| --- | --- | --- | --- | --- | --- | --- | --- | --- | --- | --- | --- | --- | --- | --- | --- | --- | --- | --- | --- | --- | --- | --- | --- | --- | --- | --- | --- | --- | --- |
| 2935 | 1.9.7 | **Transition to New Settlement Timetable (M16)** |  | 566d | 2025-10-22 | 2027-12-23 |  | 2025-10-22 | 2027-12-23 | 560d |  |  | 31573d |  | -0 | N/A | N/A | Business & Operation Readiness | -434.67 | 5.15 | N/A | Business & Operational Readiness |  |  |  |  |  |  |  |
| 2936 | 1.9.7.1 | Elexon to produce Settlement Calendar for Settlement Year 2025/2026 | milestone | 0d | 2025-10-22 | 2025-10-22 | 2709 | 2025-10-22 | 2025-10-22 | 0d |  |  | 31578d | 0d |  | PP | PP, Code Bodies | Business & Operation Readiness | 306.71 | 5.15 | Matthew Breen | Business & Operational Readiness | Green | GREEN |  |  |  |  |  |
| 2937 | 1.9.7.2 | Elexon monitor settlement data of migrated MPANs |  | 436d | 2025-10-23 | 2027-06-24 | 2936 | 2025-10-23 | 2027-06-24 | 436d |  |  | 31579d | 6d |  | PP | PP, Code Bodies | Business & Operation Readiness | 307.33 | 5.15 | Matthew Breen | Business & Operational Readiness | Green | GREEN |  |  |  |  |  |
| 2938 | 1.9.7.3 | M16 Checkpoint 1 | milestone | 0d | 2026-06-25 | 2026-06-25 | 2936FS+176d | 2026-06-25 | 2026-06-25 | 0d |  |  | 31578d | 0d |  | PP | PP, Code Bodies | Business & Operation Readiness | 552.71 | 5.15 | Matthew Breen | Business & Operational Readiness | Green | GREEN |  |  |  |  |  |
| 2939 | 1.9.7.4 | Confirm if M16 date retained as 07/12/2026 | milestone | 0d | 2026-07-23 | 2026-07-23 | 2938FS+20d | 2026-07-23 | 2026-07-23 | 0d |  |  | 31578d | 0d |  | CPT | PP | Business & Operation Readiness | 580.71 | 5.15 | Matthew Breen | Business & Operational Readiness | Green | GREEN |  |  |  |  |  |
| 2940 | 1.9.7.5 | Readiness assessment of participants' readiness to transition to new Settlement Timetable | milestone | 0d | 2026-08-20 | 2026-08-20 | 2939FS+20d | 2026-08-20 | 2026-08-20 | 0d |  |  | 31578d | 0d |  | CPT | PP | Business & Operation Readiness | 608.71 | 5.15 | Matthew Breen | Business & Operational Readiness | Green | GREEN |  |  |  |  |  |
| 2941 | 1.9.7.6 | Elexon to produce Settlement Calendar for Settlement Year 2026 up until day before M16 cutover | milestone | 0d | 2026-10-19 | 2026-10-19 | 2940FS+42d | 2026-10-19 | 2026-10-19 | 0d |  |  | 31578d | 0d |  | PP | PP, Code Bodies | Business & Operation Readiness | 668.71 | 5.15 | Matthew Breen | Business & Operational Readiness | Green | GREEN |  |  |  |  |  |
| 2942 | 1.9.7.7 | M16 Checkpoint 2 | milestone | 0d | 2027-04-02 | 2027-04-02 | 2941FS+119d | 2027-04-02 | 2027-04-02 | 0d |  |  | 31578d | 0d |  | PP | PP, Code Bodies | Business & Operation Readiness | 833.71 | 5.15 | Matthew Breen | Business & Operational Readiness | Green | GREEN |  |  |  |  |  |
| 2943 | 1.9.7.8 | Readiness assessment of participants' readiness to transition to new Settlement Timetable | milestone | 0d | 2027-04-19 | 2027-04-19 | 2942FS+11d | 2027-04-19 | 2027-04-19 | 0d |  |  | 31578d | 0d |  | CPT | PP | Business & Operation Readiness | 850.71 | 5.15 | Matthew Breen | Business & Operational Readiness | Green | GREEN |  |  |  |  |  |
| 2944 | 1.9.7.9 | Confirm M16 Date | milestone | 0d | 2027-04-30 | 2027-04-30 | 2943FS+9d | 2027-04-30 | 2027-04-30 | 1d |  |  | 31578d | 0d |  | CPT | Code Bodies,CPT,PP,SRO | Business & Operation Readiness | 861.71 | 5.3 | Matthew Breen | Business & Operational Readiness | Green | GREEN | T2-EL-0100 | PSG/BSC PAB | T2 |  |  |
| 2945 | 1.9.7.10 | Raise fast track change to ISD (November publish) | milestone | 0d | 2027-04-30 | 2027-04-30 | 2944 | 2027-04-30 | 2027-04-30 | 0d |  |  | 31618d | 45d |  | PP | PP,CPT,Code Bodies | Business & Operation Readiness | 861.71 | 5.15 | Matthew Breen | Business & Operational Readiness | Green | GREEN |  |  |  |  |  |
| 2946 | 1.9.7.11 | **M16 Approval Window** |  | 129d | 2027-06-25 | 2027-12-23 |  | 2027-06-25 | 2027-12-23 | 124d | 2026-12-07 | 2027-05-24 | 31573d |  |  | N/A | N/A | Business & Operation Readiness | 966.71 | 5.0 | N/A | Business & Operational Readiness | Green | GREEN |  |  |  |  |  |
| 2947 | 1.9.7.11.1 | Panel approval that M16 criteria met | milestone | 0d | 2027-06-25 | 2027-06-25 | 2944FS+40d | 2027-06-25 | 2027-06-25 | 0d | 2026-12-07 | 2026-12-07 | 31578d | 5d |  | Panel | Code Bodies,CPT,PP,SRO | Business & Operation Readiness | 917.71 | 5.0 | Matthew Breen | Business & Operational Readiness | Green | GREEN |  |  |  |  |  |
| 2948 | 1.9.7.11.2 | Cut over to new settlement timetable (M16) | milestone | 0d | 2027-07-02 | 2027-07-02 | 2947, 2713FS+40d, 2937, 2945, 2623 | 2027-07-02 | 2027-07-02 | 0d | 2026-12-07 | 2026-12-07 | 31573d | 0d |  | CPT | PP | Business & Operation Readiness | 924.71 | 5.0 | Matthew Breen | Business & Operational Readiness | Green | GREEN | T1-EL-1000 | PSG | T1 |  |  |
| 2949 | 1.9.7.11.3 | Maximum 6-month window for approval of M16 |  | 124d | 2027-07-05 | 2027-12-23 | 2948 | 2027-07-05 | 2027-12-23 | 124d | 2026-12-08 | 2027-05-24 | 31573d | 0d |  | CPT |  | Business & Operation Readiness | 927.33 | 5.0 | Matthew Breen | Business & Operational Readiness | Green | GREEN |  |  |  |  |  |
| 2950 | 1.9.7.11.4 | Cut over to new settlement timetable (M16*) - Late Exit | milestone | 0d | 2027-12-23 | 2027-12-23 | 2949 | 2027-12-23 | 2027-12-23 | 0d | 2027-05-24 | 2027-05-24 | 31573d |  |  | CPT | PP | Business & Operation Readiness | 1098.71 | 5.0 | Matthew Breen | Business & Operational Readiness | Green | GREEN | T1-EL-2000 | PSG | T1 |  |  |
| 2951 | 1.10 | **EARLY LIVE RUNNING** |  | 45d | 2027-05-10 | 2027-07-09 |  | 2027-05-10 | 2027-07-09 | 889d | 2024-01-02 | 2027-05-28 | 31692d |  |  | N/A | N/A | Business & Operation Readiness |  |  | N/A | Early Live Running |  |  |  |  |  | 1 Nov 2025 - 30 Apr 2026 |  |
| 2952 | 1.10.1 | **Early Live Running Stabilisation Period** |  | 45d | 2027-05-10 | 2027-07-09 |  | 2027-05-10 | 2027-07-09 | 45d | 2026-10-06 | 2026-12-07 | 31692d |  |  | N/A | N/A | Business & Operation Readiness |  | 5.0 | N/A | Early Live Running |  |  |  |  |  |  |  |
| 2953 | 1.10.1.1 | Manage Early Live Running stabilisation period |  | 45d | 2027-05-10 | 2027-07-09 | 2713 | 2027-05-10 | 2027-07-09 | 45d | 2026-10-06 | 2026-12-07 | 31692d | 0d |  | Code Bodies | PP | Business & Operation Readiness | 871.33 | 5.0 | Matthew Breen | Early Live Running | Green | GREEN |  |  |  |  |  |
| 2954 | 1.10.1.2 | Monitor Early Live Running stabilisation period |  | 45d | 2027-05-10 | 2027-07-09 | 2953SS | 2027-05-10 | 2027-07-09 | 45d | 2026-10-06 | 2026-12-07 | 31692d |  |  | SI Migration | Code Bodies,PP | Business & Operation Readiness | 871.33 | 5.0 | Matthew Breen | Early Live Running | Green | GREEN |  |  |  |  |  |
| 2955 | 1.11 | **PROGRAMME CLOSURE** |  | 80d | 2027-03-08 | 2027-06-25 |  | 2027-03-08 | 2027-06-25 | 85d | 2026-08-04 | 2026-11-30 | 31702d |  |  | N/A | N/A | Programme Closure |  |  | N/A | Programme Closure |  |  |  |  |  |  |  |
| 2956 | 1.11.1 | **Handover Pack** |  | 80d | 2027-03-08 | 2027-06-25 |  | 2027-03-08 | 2027-06-25 | 85d | 2026-08-04 | 2026-11-30 | 31702d |  |  | N/A | N/A | Programme Closure |  | 5.0 | N/A | Programme Closure |  |  |  |  |  |  |  |
| 2957 | 1.11.1.1 | **Draft Handover Pack (for M15)** |  | 40d | 2027-03-08 | 2027-04-30 |  | 2027-03-08 | 2027-04-30 | 40d | 2026-08-04 | 2026-09-28 | 31742d |  |  | N/A | N/A | Programme Closure |  | 5.0 | N/A | Programme Closure |  |  |  |  |  |  |  |
| 2958 | 1.11.1.1.1 | Develop document |  | 20d | 2027-03-08 | 2027-04-02 | 2713FS-45d | 2027-03-08 | 2027-04-02 | 20d | 2026-08-04 | 2026-08-31 | 31742d | 0d |  | PMO | CPT | Programme Closure | 808.33 | 5.0 |  | Programme Closure | Green | GREEN |  |  |  |  |  |
| 2959 | 1.11.1.1.2 | Document review and update |  | 20d | 2027-04-05 | 2027-04-30 | 2958 | 2027-04-05 | 2027-04-30 | 20d | 2026-09-01 | 2026-09-28 | 31742d | 0d |  | SRO | PMO,CPT,IPA,PP | Programme Closure | 836.33 | 5.0 |  | Programme Closure | Green | GREEN |  |  |  |  |  |
| 2960 | 1.11.1.1.3 | Draft Handover Pack approved | milestone | 0d | 2027-04-30 | 2027-04-30 | 2959 | 2027-04-30 | 2027-04-30 | 0d | 2026-09-28 | 2026-09-28 | 31742d |  |  | SRO | PMO,CPT | Programme Closure | 861.71 | 5.0 |  | Programme Closure | Green | GREEN |  |  |  |  | MHHS-ART126 |

| ID | WBS | Task | Type | Duration | Start | Finish | Predecessors | Baseline start | Baseline finish | Baseline duration | Baseline 1 start | Baseline 1 finish | Total slack | Free slack | Responsible | Involved | Text9 | Update Version | MHHS Resource Name | MHHS Programme Phase | Task Status | Sched Status | RAG | Artefact ID | Milestone ID | Text29 | Tier |
| --- | --- | --- | --- | --- | --- | --- | --- | --- | --- | --- | --- | --- | --- | --- | --- | --- | --- | --- | --- | --- | --- | --- | --- | --- | --- | --- | --- |
| 2961 | 1.11.1.2 | **Master Handover Pack (for M16)** |  | 40d | 2027-05-03 | 2027-06-25 |  | 2027-05-03 | 2027-06-25 | 40d | 2026-10-06 | 2026-11-30 | 31702d |  | N/A | N/A | Programme Closure | 5.0 | N/A | Programme Closure |  |  |  |  |  |  |  |
| 2962 | 1.11.1.2.1 | Update document |  | 20d | 2027-05-03 | 2027-05-28 | 2948FS-45d | 2027-05-03 | 2027-05-28 | 20d | 2026-10-06 | 2026-11-02 | 31702d | 0d | PMO | CPT | Programme Closure | 5.0 |  | Programme Closure | 864.33 | Green | GREEN |  |  |  |  |
| 2963 | 1.11.1.2.2 | Document review and update |  | 20d | 2027-05-31 | 2027-06-25 | 2962 | 2027-05-31 | 2027-06-25 | 20d | 2026-11-03 | 2026-11-30 | 31702d | 0d | SRO | PMO,CPT,IPA,PP | Programme Closure | 5.0 |  | Programme Closure | 892.33 | Green | GREEN |  |  |  |  |
| 2964 | 1.11.1.2.3 | Master Handover Pack approved | milestone | 0d | 2027-06-25 | 2027-06-25 | 2963 | 2027-06-25 | 2027-06-25 | 0d | 2026-11-30 | 2026-11-30 | 31702d |  | SRO | PMO,CPT | Programme Closure | 5.0 |  | Programme Closure | 917.71 | Green | GREEN | MHHS-ART126 |  |  |  |
| 2965 | 1.11.2 | **Programme Lessons Learned** |  | 40d | 2027-03-08 | 2027-04-30 |  | 2027-03-08 | 2027-04-30 | 40d | 2026-08-04 | 2026-09-28 | 31742d |  | N/A | N/A | Programme Closure | 5.0 | N/A | Programme Closure |  |  |  |  |  |  |  |
| 2966 | 1.11.2.1 | Develop document |  | 20d | 2027-03-08 | 2027-04-02 | 2713FS-45d | 2027-03-08 | 2027-04-02 | 20d | 2026-08-04 | 2026-08-31 | 31742d | 0d | PMO | CPT | Programme Closure | 5.0 |  | Programme Closure | 808.33 | Green | GREEN |  |  |  |  |
| 2967 | 1.11.2.2 | Document review and update |  | 20d | 2027-04-05 | 2027-04-30 | 2966 | 2027-04-05 | 2027-04-30 | 20d | 2026-09-01 | 2026-09-28 | 31742d | 0d | SRO | PMO,CPT,IPA | Programme Closure | 5.0 |  | Programme Closure | 836.33 | Green | GREEN |  |  |  |  |
| 2968 | 1.11.2.3 | Programme Lessons Learned document approved | milestone | 0d | 2027-04-30 | 2027-04-30 | 2967 | 2027-04-30 | 2027-04-30 | 0d | 2026-09-28 | 2026-09-28 | 31742d |  | SRO | PMO,CPT | Programme Closure | 5.0 |  | Programme Closure | 861.71 | Green | GREEN | MHHS-ART131 |  |  |  |
| 2969 | 1.11.3 | **Programme Closure Report** |  | 40d | 2027-03-08 | 2027-04-30 |  | 2027-03-08 | 2027-04-30 | 40d | 2026-08-04 | 2026-09-28 | 31742d |  | N/A | N/A | Programme Closure | 5.0 | N/A | Programme Closure |  |  |  |  |  |  |  |
| 2970 | 1.11.3.1 | Develop document |  | 20d | 2027-03-08 | 2027-04-02 | 2713FS-45d | 2027-03-08 | 2027-04-02 | 20d | 2026-08-04 | 2026-08-31 | 31742d | 0d | PMO | CPT | Programme Closure | 5.0 |  | Programme Closure | 808.33 | Green | GREEN |  |  |  |  |
| 2971 | 1.11.3.2 | Document review and update |  | 20d | 2027-04-05 | 2027-04-30 | 2970 | 2027-04-05 | 2027-04-30 | 20d | 2026-09-01 | 2026-09-28 | 31742d | 0d | Ofgem | PMO,CPT,IPA,SRO | Programme Closure | 5.0 |  | Programme Closure | 836.33 | Green | GREEN |  |  |  |  |
| 2972 | 1.11.3.3 | Programme Closure Report approved | milestone | 0d | 2027-04-30 | 2027-04-30 | 2971 | 2027-04-30 | 2027-04-30 | 0d | 2026-09-28 | 2026-09-28 | 31742d |  | Ofgem | PMO,CPT,IPA,SRO | Programme Closure | 5.0 |  | Programme Closure | 861.71 | Green | GREEN | MHHS-ART130 |  |  |  |
| 2973 | 1.11.4 | **Benefit Realisation Report** |  | 45d | 2027-03-08 | 2027-05-07 |  | 2027-03-08 | 2027-05-07 | 45d | 2026-08-04 | 2026-10-05 | 31737d |  | N/A | N/A | Programme Closure | 5.0 | N/A | Programme Closure |  |  |  |  |  |  |  |
| 2974 | 1.11.4.1 | Develop document |  | 20d | 2027-03-08 | 2027-04-02 | 2713FS-45d | 2027-03-08 | 2027-04-02 | 20d | 2026-08-04 | 2026-08-31 | 31737d | 0d | PMO | CPT | Programme Closure | 5.0 |  | Programme Closure | 808.33 | Green | GREEN |  |  |  |  |
| 2975 | 1.11.4.2 | Document review and update |  | 20d | 2027-04-05 | 2027-04-30 | 2974 | 2027-04-05 | 2027-04-30 | 20d | 2026-09-01 | 2026-09-28 | 31737d | 0d | PP | PMO,CPT,IPA,SRO | Programme Closure | 5.0 |  | Programme Closure | 836.33 | Green | GREEN |  |  |  |  |
| 2976 | 1.11.4.3 | Benefit Realisation Report approved | milestone | 0d | 2027-05-07 | 2027-05-07 | 2975FS+5d | 2027-05-07 | 2027-05-07 | 0d | 2026-10-05 | 2026-10-05 | 31737d |  | PMO | CPT,PP,IPA,SRO | Programme Closure | 5.0 |  | Programme Closure | 868.71 | Green | GREEN | MHHS-ART124 | T3-PC-0010 | PSG | T3 |
| 2977 | 1.11.5 | **Operating Model Gap Review with recommendations** |  | 45d | 2027-03-08 | 2027-05-07 |  | 2027-03-08 | 2027-05-07 | 45d | 2026-08-04 | 2026-10-05 | 31737d |  | N/A | N/A | Programme Closure | 5.0 | N/A | Programme Closure |  |  |  |  |  |  |  |
| 2978 | 1.11.5.1 | Develop document |  | 20d | 2027-03-08 | 2027-04-02 | 2713FS-45d | 2027-03-08 | 2027-04-02 | 20d | 2026-08-04 | 2026-08-31 | 31737d | 0d | PMO | CPT | Programme Closure | 5.0 |  | Programme Closure | 808.33 | Green | GREEN |  |  |  |  |
| 2979 | 1.11.5.2 | Document review and update |  | 20d | 2027-04-05 | 2027-04-30 | 2978 | 2027-04-05 | 2027-04-30 | 20d | 2026-09-01 | 2026-09-28 | 31737d | 0d | PP | PMO,CPT,IPA,SRO | Programme Closure | 5.0 |  | Programme Closure | 836.33 | Green | GREEN |  |  |  |  |
| 2980 | 1.11.5.3 | Operating Model Gap Review with recommendations approved | milestone | 0d | 2027-05-07 | 2027-05-07 | 2979FS+5d | 2027-05-07 | 2027-05-07 | 0d | 2026-10-05 | 2026-10-05 | 31737d |  | Paul Pettitt | CPT,PP,IPA,SRO | Programme Closure | 5.0 | Paul Pettitt | Programme Closure | 868.71 | Green | GREEN | MHHS-ART128 | T3-PC-0020 | DAG | T3 |
| 2981 | 1.11.6 | **Post-Implementation Review** |  | 45d | 2027-03-08 | 2027-05-07 |  | 2027-03-08 | 2027-05-07 | 45d | 2026-08-04 | 2026-10-05 | 31737d |  | N/A | N/A | Programme Closure | 5.0 | N/A | Programme Closure |  |  |  |  |  |  |  |
| 2982 | 1.11.6.1 | Develop document |  | 20d | 2027-03-08 | 2027-04-02 | 2713FS-45d | 2027-03-08 | 2027-04-02 | 20d | 2026-08-04 | 2026-08-31 | 31737d | 0d | PMO | CPT | Programme Closure | 5.0 |  | Programme Closure | 808.33 | Green | GREEN |  |  |  |  |
| 2983 | 1.11.6.2 | Document review and update |  | 20d | 2027-04-05 | 2027-04-30 | 2982 | 2027-04-05 | 2027-04-30 | 20d | 2026-09-01 | 2026-09-28 | 31737d | 0d | PP | PMO,CPT,IPA,SRO | Programme Closure | 5.0 |  | Programme Closure | 836.33 | Green | GREEN |  |  |  |  |
| 2984 | 1.11.6.3 | Post-Implementation Review approved | milestone | 0d | 2027-05-07 | 2027-05-07 | 2983FS+5d | 2027-05-07 | 2027-05-07 | 0d | 2026-10-05 | 2026-10-05 | 31737d |  | PMO | CPT,PP,IPA,SRO | Programme Closure | 5.0 |  | Programme Closure | 868.71 | Green | GREEN | MHHS-ART129 | T3-PC-0030 | PSG | T3 |

Notes:
- 2980: Action: 5/2 - PP said ask MB if belonged to him. MB says doesn't sit with him

| ID | WBS | Task | Type | Duration | Start | Finish | Predecessors | Complete | Remaining | Baseline start | Baseline finish | Baseline duration | Baseline 1 start | Baseline 1 finish | Total slack | Free slack | Constraint | Responsible | Involved | Text9 | Update Version | MHHS Resource Name | MHHS Programme Phase | Task Status | Sched Status | RAG | Artefact ID | Milestone ID | Text29 | Tier | Future RAG |
| --- | --- | --- | --- | --- | --- | --- | --- | --- | --- | --- | --- | --- | --- | --- | --- | --- | --- | --- | --- | --- | --- | --- | --- | --- | --- | --- | --- | --- | --- | --- | --- |
| 2985 | 1.11.7 | **Reinforcement Guide** |  | 45d | 2027-03-08 | 2027-05-07 |  |  |  | 2027-03-08 | 2027-05-07 | 45d | 2026-08-04 | 2026-10-05 | 31737d |  |  | N/A | N/A | Programme Closure | 5.0 | N/A | Programme Closure |  |  |  |  |  |  |  |  |
| 2986 | 1.11.7.1 | Develop document |  | 20d | 2027-03-08 | 2027-04-02 | 2713FS-45d |  |  | 2027-03-08 | 2027-04-02 | 20d | 2026-08-04 | 2026-08-31 | 31737d | 0d |  | PMO | CPT | Programme Closure | 5.0 |  | Programme Closure | 808.33 | Green | GREEN |  |  |  |  |  |
| 2987 | 1.11.7.2 | Document review and update |  | 20d | 2027-04-05 | 2027-04-30 | 2986 |  |  | 2027-04-05 | 2027-04-30 | 20d | 2026-09-01 | 2026-09-28 | 31737d | 0d |  | PP | PMO,CPT,IPA,SRO | Programme Closure | 5.0 |  | Programme Closure | 836.33 | Green | GREEN |  |  |  |  |  |
| 2988 | 1.11.7.3 | Reinforcement Guide approved | milestone | 0d | 2027-05-07 | 2027-05-07 | 2987FS+5d |  |  | 2027-05-07 | 2027-05-07 | 0d | 2026-10-05 | 2026-10-05 | 31737d |  |  | PMO | CPT,PP,IPA,SRO | Programme Closure | 5.0 |  | Programme Closure | 868.71 | Green | GREEN | MHHS-ART133 | T3-PC-0040 | PSG | T3 |  |
| 2989 | 1.11.8 | **Material and Licenses Transfer** |  | 60d | 2027-04-05 | 2027-06-25 |  |  |  | 2027-04-05 | 2027-06-25 | 60d | 2026-09-08 | 2026-11-30 | 31702d |  |  | N/A | N/A | Programme Closure | 5.0 | N/A | Programme Closure |  |  |  |  |  |  |  |  |
| 2990 | 1.11.8.1 | Transfer of Programme material to Elexon and perpetual licenses as appropriate |  | 60d | 2027-04-05 | 2027-06-25 | 2948FF-5d |  |  | 2027-04-05 | 2027-06-25 | 60d | 2026-09-08 | 2026-11-30 | 31702d |  |  | PMO | CPT,PP | Programme Closure | 5.0 |  | Programme Closure | 836.33 | Green | GREEN | MHHS-ART139 |  |  |  |  |
| 2991 | 1.12 | **READINESS ASSESSMENTS** |  | 988d | 2023-09-05 A | 2027-06-17 |  | 23% | 764.9d | 2023-09-05 | 2027-06-17 | 849d | 2023-09-11 | 2026-12-04 | 31708d |  |  | N/A | N/A | Readiness Assessment |  | N/A | Readiness Assessments |  |  |  |  |  |  |  |  |
| 2992 | 1.12.1 | **Readiness Assessment 3 - Design and Build Progress Check and CP2 Check** |  | 60d | 2023-09-05 A | 2023-11-27 A |  | 100% |  | 2023-09-05 | 2023-11-27 | 50d | 2023-09-11 | 2023-11-17 |  |  |  | N/A | N/A | Readiness Assessment | 5.5 | N/A | Readiness Assessments | M5,M6 |  |  |  |  |  |  |  |
| 2993 | 1.12.1.1 | Launch Readiness Assessment survey | milestone | 0d | 2023-09-05 A | 2023-09-05 A | 1483FS-40d | 100% |  | 2023-09-05 | 2023-09-05 | 0d | 2023-09-11 | 2023-09-11 |  |  |  | PPC |  | Readiness Assessment | 5.5 | PPC | Readiness Assessments |  | Complete | COMPLETE |  |  |  |  |  |
| 2994 | 1.12.1.2 | PPs submit survey responses |  | 15d | 2023-09-05 A | 2023-09-25 A | 2993 | 100% |  | 2023-09-05 | 2023-09-25 | 15d | 2023-09-11 | 2023-09-29 |  |  |  | PP | PPC | Readiness Assessment | 5.5 | PPC | Readiness Assessments |  | Complete | COMPLETE |  |  |  |  |  |
| 2995 | 1.12.1.3 | Analyse survey responses |  | 15d | 2023-09-26 A | 2023-10-16 A | 2994 | 100% |  | 2023-09-26 | 2023-10-16 | 15d | 2023-10-02 | 2023-10-20 |  |  |  | PPC | CPT | Readiness Assessment | 5.5 | PPC | Readiness Assessments |  | Complete | COMPLETE |  |  |  |  |  |
| 2996 | 1.12.1.4 | Conduct deep-dive interviews (sample of PPs) |  | 15d | 2023-09-26 A | 2023-10-16 A | 2994 | 100% |  | 2023-09-26 | 2023-10-16 | 15d | 2023-10-02 | 2023-10-20 |  |  |  | PPC | CPT | Readiness Assessment | 5.5 | PPC | Readiness Assessments |  | Complete | COMPLETE |  |  |  |  |  |
| 2997 | 1.12.1.5 | Produce Readiness Assessment Reports (Overall Report & Individual Participant Reports) |  | 25d | 2023-10-17 A | 2023-11-20 A | 2995, 2996 | 100% |  | 2023-10-17 | 2023-11-20 | 15d | 2023-10-23 | 2023-11-10 |  |  |  | PPC |  | Readiness Assessment | 5.5 | PPC | Readiness Assessments |  | Complete | COMPLETE |  |  |  |  |  |
| 2998 | 1.12.1.6 | Readiness Assessment 3 - Design & Build Checkpoint 1 - Completed (incl. Readiness Assessment Report approval) | milestone | 0d | 2023-11-27 A | 2023-11-27 A | 2997FS+5d | 100% |  | 2023-11-27 | 2023-11-27 | 0d | 2023-11-17 | 2023-11-17 |  |  |  | CPT | PPC | Readiness Assessment | 5.13 | PPC | Readiness Assessments |  | Complete | COMPLETE |  | T2-RA-0200 | PSG | T2 |  |
| 2999 | 1.12.2 | **Readiness Assessment 5 / 6 - Start of Qualification and Participant Readiness for M10 and M11 and CP3/CP4 check** |  | 47d | 2025-04-21 | 2025-06-24 |  |  |  | 2025-04-21 | 2025-06-24 | 49d | 2024-11-12 | 2025-01-17 | 32225d |  |  | N/A | N/A | Readiness Assessment | 5.0 | N/A | Readiness Assessments | M11 |  |  |  |  |  |  | D25 - RA6 Readiness Report |
| 3000 | 1.12.2.1 | Launch Readiness Assessment survey | milestone | 0d | 2025-04-21 | 2025-04-21 |  |  |  | 2025-04-21 | 2025-04-21 | 0d | 2024-11-12 | 2024-11-12 | 32225d | 0d | start no earlier than 2025-04-21 | PPC |  | Readiness Assessment | 5.0 | PPC | Readiness Assessments | 122.33 | Green | GREEN |  |  |  |  |  |
| 3001 | 1.12.2.2 | PPs submit survey responses |  | 15d | 2025-04-21 | 2025-05-09 | 3000 |  |  | 2025-04-21 | 2025-05-09 | 15d | 2024-11-12 | 2024-12-02 | 32225d | 0d |  | PP | PPC | Readiness Assessment | 5.0 | PPC | Readiness Assessments | 122.33 | Green | GREEN |  |  |  |  |  |
| 3002 | 1.12.2.3 | Analyse survey responses |  | 15d | 2025-05-12 | 2025-05-30 | 3001 |  |  | 2025-05-12 | 2025-05-30 | 15d | 2024-12-03 | 2024-12-23 | 32225d | 0d |  | PPC | CPT | Readiness Assessment | 5.0 | PPC | Readiness Assessments | 143.33 | Green | GREEN |  |  |  |  |  |
| 3003 | 1.12.2.4 | Conduct deep-dive interviews (sample of PPs) |  | 15d | 2025-05-12 | 2025-05-30 | 3001 |  |  | 2025-05-12 | 2025-05-30 | 15d | 2024-12-03 | 2024-12-23 | 32225d | 0d |  | PPC | CPT | Readiness Assessment | 5.0 | PPC | Readiness Assessments | 143.33 | Green | GREEN |  |  |  |  |  |
| 3004 | 1.12.2.5 | Produce Readiness Assessment Reports (Overall Report & Individual Participant Reports) |  | 15d | 2025-06-02 | 2025-06-20 | 3002, 3003 |  |  | 2025-06-02 | 2025-06-20 | 15d | 2024-12-24 | 2025-01-13 | 32225d | 0d |  | PPC |  | Readiness Assessment | 5.0 | PPC | Readiness Assessments | 164.33 | Green | GREEN |  |  |  |  |  |
| 3005 | 1.12.2.6 | Readiness Assessment 5 / 6 - Start of Qualification and Participant Readiness for M10 and M11 and CP3/CP4 check (incl. Readiness Assessment Report approval) Completed | milestone | 0d | 2025-06-24 | 2025-06-24 | 3004FS+2d |  |  | 2025-06-24 | 2025-06-24 | 0d | 2025-01-17 | 2025-01-17 | 32225d | 0d |  | CPT | PPC | Readiness Assessment | 5.18 | PPC | Readiness Assessments | 186.71 | Green | GREEN |  | T2-RA-0400 | PSG | T2 |  |
| 3006 | 1.12.3 | **Readiness Assessment 7 - Migration Checkpoint** |  | 49d | 2026-01-12 | 2026-03-19 |  |  |  | 2026-01-12 | 2026-03-19 | 49d | 2025-08-04 | 2025-10-09 | 32033d |  |  | N/A | N/A | Readiness Assessment | 5.0 | N/A | Readiness Assessments | M14 |  |  |  |  |  |  | D29 - RA8 Readiness Report |
| 3007 | 1.12.3.1 | Launch Readiness Assessment survey | milestone | 0d | 2026-01-12 | 2026-01-12 |  |  |  | 2026-01-12 | 2026-01-12 | 0d | 2025-08-04 | 2025-08-04 | 32033d | 0d | start no earlier than 2026-01-12 | PPC |  | Readiness Assessment | 5.0 | PPC | Readiness Assessments | 388.33 | Green | GREEN |  |  |  |  |  |
| 3008 | 1.12.3.2 | PPs submit survey responses |  | 15d | 2026-01-12 | 2026-01-30 | 3007 |  |  | 2026-01-12 | 2026-01-30 | 15d | 2025-08-04 | 2025-08-22 | 32033d | 0d |  | PP | PPC | Readiness Assessment | 5.0 | PPC | Readiness Assessments | 388.33 | Green | GREEN |  |  |  |  |  |
| 3009 | 1.12.3.3 | Analyse survey responses |  | 15d | 2026-02-02 | 2026-02-20 | 3008 |  |  | 2026-02-02 | 2026-02-20 | 15d | 2025-08-25 | 2025-09-12 | 32033d | 0d |  | PPC | CPT | Readiness Assessment | 5.0 | PPC | Readiness Assessments | 409.33 | Green | GREEN |  |  |  |  |  |
| 3010 | 1.12.3.4 | Conduct deep-dive interviews (sample of PPs) |  | 15d | 2026-02-02 | 2026-02-20 | 3008 |  |  | 2026-02-02 | 2026-02-20 | 15d | 2025-08-25 | 2025-09-12 | 32033d | 0d |  | PPC | CPT | Readiness Assessment | 5.0 | PPC | Readiness Assessments | 409.33 | Green | GREEN |  |  |  |  |  |
| 3011 | 1.12.3.5 | Produce Readiness Assessment Reports (Overall Report & Individual Participant Reports) |  | 15d | 2026-02-23 | 2026-03-13 | 3009, 3010 |  |  | 2026-02-23 | 2026-03-13 | 15d | 2025-09-15 | 2025-10-03 | 32033d | 0d |  | PPC |  | Readiness Assessment | 5.0 | PPC | Readiness Assessments | 430.33 | Green | GREEN |  |  |  |  |  |
| 3012 | 1.12.3.6 | Readiness Assessment 7 - Migration Checkpoint - Completed (incl. Readiness Assessment Report approval) | milestone | 0d | 2026-03-19 | 2026-03-19 | 3011FS+4d |  |  | 2026-03-19 | 2026-03-19 | 0d | 2025-10-09 | 2025-10-09 | 32033d | 0d |  | CPT | PPC | Readiness Assessment | 5.0 | PPC | Readiness Assessments | 454.71 | Green | GREEN |  | T2-RA-0600 | PSG | T2 |  |

Notes:
- 2996: 16/11- FD confirmed activity didn't take place for RA3 because responses did not warrant follow-up
- 2998: 16/11-RA3 outputs and initial findings shared with PSG to support M9 decision making. Individual reports and final closure report being finalised. No impact to Programme timelines or activities
- 3005: 08/02/2024 Name change approval at PSG on 07/02/24 from Readiness Assessment 5 - Start of Qualification - Completed (incl. Readiness Assessment Report approval)

| ID | WBS | Task | Type | Duration | Start | Finish | Predecessors | Complete | Remaining | Baseline start | Baseline finish | Baseline duration | Baseline 1 start | Baseline 1 finish | Total slack | Free slack | Constraint | Responsible | Involved | Future RAG | Text9 | Task Status | Update Version | MHHS Resource Name | MHHS Programme Phase | Sched Status | RAG | Milestone ID | Text29 | Tier |
| --- | --- | --- | --- | --- | --- | --- | --- | --- | --- | --- | --- | --- | --- | --- | --- | --- | --- | --- | --- | --- | --- | --- | --- | --- | --- | --- | --- | --- | --- | --- |
| 3013 | 1.12.4 | **Readiness Assessment 8 - Ready to Accept New MPANs** |  | 49d | 2026-08-06 | 2026-10-13 |  |  |  | 2026-08-06 | 2026-10-13 | 49d | 2026-01-06 | 2026-03-13 | 31885d |  |  | N/A | N/A | D29 - RA8 Readiness Report | Readiness Assessment | M14 | 5.0 | N/A | Readiness Assessments |  |  |  |  |  |
| 3014 | 1.12.4.1 | Launch Readiness Assessment survey | milestone | 0d | 2026-08-06 | 2026-08-06 | 2305FS-60d |  |  | 2026-08-06 | 2026-08-06 | 0d | 2026-01-06 | 2026-01-06 | 31885d | 0d |  | PPC |  |  | Readiness Assessment | 594.33 | 5.0 | PPC | Readiness Assessments | Green | GREEN |  |  |  |
| 3015 | 1.12.4.2 | PPs submit survey responses |  | 15d | 2026-08-06 | 2026-08-26 | 3014 |  |  | 2026-08-06 | 2026-08-26 | 15d | 2026-01-06 | 2026-01-26 | 31885d | 0d |  | PP | PPC |  | Readiness Assessment | 594.33 | 5.0 | PPC | Readiness Assessments | Green | GREEN |  |  |  |
| 3016 | 1.12.4.3 | Analyse survey responses |  | 15d | 2026-08-27 | 2026-09-16 | 3015 |  |  | 2026-08-27 | 2026-09-16 | 15d | 2026-01-27 | 2026-02-16 | 31885d | 0d |  | PPC | CPT |  | Readiness Assessment | 615.33 | 5.0 | PPC | Readiness Assessments | Green | GREEN |  |  |  |
| 3017 | 1.12.4.4 | Conduct deep-dive interviews (sample of PPs) |  | 15d | 2026-08-27 | 2026-09-16 | 3015 |  |  | 2026-08-27 | 2026-09-16 | 15d | 2026-01-27 | 2026-02-16 | 31885d | 0d |  | PPC | CPT |  | Readiness Assessment | 615.33 | 5.0 | PPC | Readiness Assessments | Green | GREEN |  |  |  |
| 3018 | 1.12.4.5 | Produce Readiness Assessment Reports (Overall Report & Individual Participant Reports) |  | 15d | 2026-09-17 | 2026-10-07 | 3016, 3017 |  |  | 2026-09-17 | 2026-10-07 | 15d | 2026-02-17 | 2026-03-09 | 31885d | 0d |  | PPC |  |  | Readiness Assessment | 636.33 | 5.0 | PPC | Readiness Assessments | Green | GREEN |  |  |  |
| 3019 | 1.12.4.6 | Readiness Assessment 8 - Ready to Accept New MPANs - Completed (incl. Readiness Assessment Report approval) | milestone | 0d | 2026-10-13 | 2026-10-13 | 3018FS+4d |  |  | 2026-10-13 | 2026-10-13 | 0d | 2026-03-13 | 2026-03-13 | 31885d | 0d |  | CPT | PPC |  | Readiness Assessment | 662.71 | 5.0 | PPC | Readiness Assessments | Green | GREEN | T2-RA-0700 | PSG | T2 |
| 3020 | 1.12.5 | **Readiness Assessment 9 - Ready for New Settlement Timetable and CP5 Check** |  | 49d | 2027-04-12 | 2027-06-17 |  |  |  | 2027-04-12 | 2027-06-17 | 49d | 2026-09-29 | 2026-12-04 | 31708d |  |  | N/A | N/A | D32 - RA10 Readiness Report | Readiness Assessment | M16 | 5.0 | N/A | Readiness Assessments |  |  |  |  |  |
| 3021 | 1.12.5.1 | Launch Readiness Assessment survey | milestone | 0d | 2027-04-12 | 2027-04-12 | 2948FS-60d |  |  | 2027-04-12 | 2027-04-12 | 0d | 2026-09-29 | 2026-09-29 | 31708d | 0d |  | PPC |  |  | Readiness Assessment | 843.33 | 5.0 | PPC | Readiness Assessments | Green | GREEN |  |  |  |
| 3022 | 1.12.5.2 | PPs submit survey responses |  | 15d | 2027-04-12 | 2027-04-30 | 3021 |  |  | 2027-04-12 | 2027-04-30 | 15d | 2026-09-29 | 2026-10-19 | 31708d | 0d |  | PP | PPC |  | Readiness Assessment | 843.33 | 5.0 | PPC | Readiness Assessments | Green | GREEN |  |  |  |
| 3023 | 1.12.5.3 | Analyse survey responses |  | 15d | 2027-05-03 | 2027-05-21 | 3022 |  |  | 2027-05-03 | 2027-05-21 | 15d | 2026-10-20 | 2026-11-09 | 31708d | 0d |  | PPC | CPT |  | Readiness Assessment | 864.33 | 5.0 | PPC | Readiness Assessments | Green | GREEN |  |  |  |
| 3024 | 1.12.5.4 | Conduct deep-dive interviews (sample of PPs) |  | 15d | 2027-05-03 | 2027-05-21 | 3022 |  |  | 2027-05-03 | 2027-05-21 | 15d | 2026-10-20 | 2026-11-09 | 31708d | 0d |  | PPC | CPT |  | Readiness Assessment | 864.33 | 5.0 | PPC | Readiness Assessments | Green | GREEN |  |  |  |
| 3025 | 1.12.5.5 | Produce Readiness Assessment Reports (Overall Report & Individual Participant Reports) |  | 15d | 2027-05-24 | 2027-06-11 | 3023, 3024 |  |  | 2027-05-24 | 2027-06-11 | 15d | 2026-11-10 | 2026-11-30 | 31708d | 0d |  | PPC |  |  | Readiness Assessment | 885.33 | 5.0 | PPC | Readiness Assessments | Green | GREEN |  |  |  |
| 3026 | 1.12.5.6 | Readiness Assessment 9 - Readiness for New Settlement Timetable - Completed (incl. Readiness Assessment Report approval) | milestone | 0d | 2027-06-17 | 2027-06-17 | 3025FS+4d |  |  | 2027-06-17 | 2027-06-17 | 0d | 2026-12-04 | 2026-12-04 | 31708d | 0d |  | CPT | PPC |  | Readiness Assessment | 909.71 | 5.0 | PPC | Readiness Assessments | Green | GREEN | T2-RA-0800 | PSG | T2 |
| 3027 | 1.12.6 | **Readiness Assessments - Tier 1 Milestones** |  | 517d | 2025-06-24 | 2027-06-17 |  |  |  | 2025-06-24 | 2027-06-17 | 799d | 2023-11-17 | 2026-12-04 | 31708d |  |  | N/A | N/A |  | Readiness Assessment |  | 5.0 | N/A | Readiness Assessments |  |  |  |  |  |
| 3028 | 1.12.6.1 | Readiness Assessment 6 - Start of Migration - Completed (incl. Readiness Assessment Report approval) | milestone | 0d | 2025-06-24 | 2025-06-24 | 3005 |  |  | 2025-06-24 | 2025-06-24 | 0d | 2025-04-04 | 2025-04-04 | 32225d |  | finish no earlier than 2025-04-04 | CPT | PPC |  | Readiness Assessment | 186.71 | 5.0 | PPC | Readiness Assessments | Green | GREEN | T2-RA-0500 | PSG | T2 |
| 3029 | 1.12.6.2 | Readiness Assessment 7 - Migration Checkpoint - Completed (incl. Readiness Assessment Report approval) | milestone | 0d | 2026-03-19 | 2026-03-19 | 3012 |  |  | 2026-03-19 | 2026-03-19 | 0d | 2025-10-09 | 2025-10-09 | 32033d |  |  | CPT | PPC |  | Readiness Assessment | 454.71 | 5.0 | PPC | Readiness Assessments | Green | GREEN | T2-RA-0600 | PSG | T2 |
| 3030 | 1.12.6.3 | Readiness Assessment 8 - Ready to Accept New MPANs - Completed (incl. Readiness Assessment Report approval) | milestone | 0d | 2026-10-13 | 2026-10-13 | 3019 |  |  | 2026-10-13 | 2026-10-13 | 0d | 2026-03-13 | 2026-03-13 | 31885d |  |  | CPT | PPC |  | Readiness Assessment | 662.71 | 5.0 | PPC | Readiness Assessments | Green | GREEN | T2-RA-0700 | PSG | T2 |
| 3031 | 1.12.6.4 | Readiness Assessment 9 - Readiness for New Settlement Timetable - Completed (incl. Readiness Assessment Report approval) | milestone | 0d | 2027-06-17 | 2027-06-17 | 3026 |  |  | 2027-06-17 | 2027-06-17 | 0d | 2026-12-04 | 2026-12-04 | 31708d |  |  | CPT | PPC |  | Readiness Assessment | 909.71 | 5.0 | PPC | Readiness Assessments | Green | GREEN | T2-RA-0800 | PSG | T2 |
| 3032 | 1.13 | **CONTROL POINTS** |  | 1204d | 2022-11-10 A | 2027-06-23 |  | 51% | 591.8d | 2022-11-10 | 2027-06-23 | 1063d | 2022-11-10 | 2026-12-07 | 31705d |  |  | N/A | N/A |  | Control Points |  |  | N/A | Control Points |  |  |  |  |  |
| 3033 | 1.13.1 | **Control Point 1 - Start of System Design, Build & Test** |  | 20d | 2022-11-10 A | 2022-12-07 A |  | 100% |  | 2022-11-10 | 2022-12-07 | 20d | 2022-11-10 | 2022-12-07 |  |  |  | N/A | N/A |  | Control Points |  | 5.0 | N/A | Control Points |  |  |  |  |  |
| 3034 | 1.13.1.1 | Control Point 1 Preparation (incl. Control Point Report development and review) |  | 15d | 2022-11-10 A | 2022-11-30 A | 3035SS-20d | 100% |  | 2022-11-10 | 2022-11-30 | 15d | 2022-11-10 | 2022-11-30 |  |  |  | CPT | PMO |  | Control Points |  | 5.0 | PMO | Control Points | Complete | COMPLETE |  |  |  |
| 3035 | 1.13.1.2 | Control Point 1 - Start of System Design, Build & Test (incl. Control Point Report approval) | milestone | 0d | 2022-12-07 A | 2022-12-07 A |  | 100% |  | 2022-12-07 | 2022-12-07 | 0d | 2022-12-07 | 2022-12-07 |  |  | must finish on 2022-12-07 | CPT | PMO | D24 - CP2 Approval | Control Points |  | 5.0 | PMO | Control Points | Complete | COMPLETE | T1-CP-1000 | PSG | T1 |
| 3036 | 1.13.2 | **Control Point 2 - Start of Integration & Test** |  | 20d | 2023-10-02 A | 2023-10-30 A |  | 100% |  | 2023-10-02 | 2023-10-30 | 20d | 2023-10-02 | 2023-10-30 |  |  |  | N/A | N/A |  | Control Points |  | 5.0 | N/A | Control Points |  |  |  |  |  |
| 3037 | 1.13.2.1 | Control Point 2 Preparation (incl. Control Point Report development and review) |  | 15d | 2023-10-02 A | 2023-10-20 A | 3038SS-20d | 100% |  | 2023-10-02 | 2023-10-20 | 15d | 2023-10-02 | 2023-10-20 |  |  |  | CPT | PMO |  | Control Points |  | 5.0 | PMO | Control Points | Complete | COMPLETE |  |  |  |
| 3038 | 1.13.2.2 | Control Point 2 - Start of Integration & Test (incl. Control Point Report approval) | milestone | 0d | 2023-10-30 A | 2023-10-30 A | 1483 | 100% |  | 2023-10-30 | 2023-10-30 | 0d | 2023-10-30 | 2023-10-30 |  |  |  | CPT | PMO | D24 - CP2 Approval | Control Points |  | 5.11 | PMO | Control Points | Complete | COMPLETE | T1-CP-2000 | PSG | T1 |

| ID | WBS | Task | Type | Duration | Start | Finish | Predecessors | Complete | Remaining | Baseline start | Baseline finish | Baseline duration | Baseline 1 start | Baseline 1 finish | Total slack | Free slack | Responsible | Involved | Future RAG | Text9 | Update Version | MHHS Resource Name | MHHS Programme Phase | Task Status | Sched Status | RAG | Milestone ID | Text29 | Tier |
| --- | --- | --- | --- | --- | --- | --- | --- | --- | --- | --- | --- | --- | --- | --- | --- | --- | --- | --- | --- | --- | --- | --- | --- | --- | --- | --- | --- | --- | --- |
| 3039 | 1.13.3 | **Control Point 3/4 - Readiness for Migration** |  | 20d | 2025-08-21 | 2025-09-18 |  |  |  | 2025-08-21 | 2025-09-18 | 20d | 2025-03-03 | 2025-03-28 | 32164d |  | N/A | N/A | D26 - CP3 Approval | Control Points | 5.0 | N/A | Control Points |  |  |  |  |  |  |
| 3040 | 1.13.3.1 | Control Point 3/4 Preparation (incl. Control Point Report development and review) |  | 14d | 2025-08-21 | 2025-09-09 | 3041SS-20d |  |  | 2025-08-21 | 2025-09-09 | 14d | 2025-03-03 | 2025-03-21 | 32170d |  | CPT | PMO |  | Control Points | 5.0 | PMO | Control Points | 244.33 | Green | GREEN |  |  |  |
| 3041 | 1.13.3.2 | Control Point 3/4 - Readiness for Migration (incl. Control Point Report approval) | milestone | 0d | 2025-09-18 | 2025-09-18 | 1774FS-5d |  |  | 2025-09-18 | 2025-09-18 | 0d | 2025-03-28 | 2025-03-28 | 32164d | 0d | CPT | PMO |  | Control Points | 5.0 | PMO | Control Points | 272.33 | Green | GREEN | T1-CP-3000 | PSG | T1 |
| 3042 | 1.13.4 | **Control Point 5 - Cut Over to New Settlement Timetable** |  | 20d | 2027-05-26 | 2027-06-23 |  |  |  | 2027-05-26 | 2027-06-23 | 20d | 2026-11-10 | 2026-12-07 | 31705d |  | N/A | N/A | D33 - Control Point 6 Approval | Control Points | 5.0 | N/A | Control Points | M16 |  |  |  |  |  |
| 3043 | 1.13.4.1 | Control Point 5 Preparation (incl. Control Point Report development and review) |  | 15d | 2027-05-26 | 2027-06-15 | 3044SS-20d |  |  | 2027-05-26 | 2027-06-15 | 15d | 2026-11-10 | 2026-11-30 | 31710d |  | CPT | PP |  | Control Points | 5.0 | PMO | Control Points | 887.33 | Green | GREEN |  |  |  |
| 3044 | 1.13.4.2 | Control Point 5 - Cut Over to New Settlement Timetable (incl. Control Point Report approval) | milestone | 0d | 2027-06-23 | 2027-06-23 | 2948FS-8d |  |  | 2027-06-23 | 2027-06-23 | 0d | 2026-12-07 | 2026-12-07 | 31705d | 0d | CPT | CPT | D33 - Control Point 6 Approval | Control Points | 5.0 | PMO | Control Points | 915.33 | Green | GREEN | T1-CP-4000 | PSG | T1 |
| 3045 | 1.13.5 | **Control Points - Tier 1 Milestones** |  | 1184d | 2022-12-07 A | 2027-06-23 |  |  | 1184d | 2022-12-07 | 2027-06-23 | 1043d | 2022-12-07 | 2026-12-07 | 31705d |  | N/A | N/A |  | Control Points | 5.0 | N/A | Control Points |  |  |  |  |  |  |
| 3046 | 1.13.5.1 | Control Point 1 - Start of System Design, Build & Test (incl. Control Point Report approval) | milestone | 0d | 2022-12-07 A | 2022-12-07 A | 3035SS | 100% |  | 2022-12-07 | 2022-12-07 | 0d | 2022-12-07 | 2022-12-07 |  |  | CPT | PMO |  | Control Points | 5.0 | PMO | Control Points |  | Complete | COMPLETE | T1-CP-1000 | PSG | T1 |
| 3047 | 1.13.5.2 | Control Point 2 - Start of Integration & Test (incl. Control Point Report approval) | milestone | 0d | 2023-10-30 A | 2023-10-30 A | 3038SS | 100% |  | 2023-10-30 | 2023-10-30 | 0d | 2023-10-30 | 2023-10-30 |  |  | CPT | PMO | D24 - CP2 Approval | Control Points | 5.11 | PMO | Control Points |  | Complete | COMPLETE | T1-CP-2000 | PSG | T1 |
| 3048 | 1.13.5.3 | Control Point 3/4 - Readiness for Migration (incl. Control Point Report approval) | milestone | 0d | 2025-09-18 | 2025-09-18 | 3041SS |  |  | 2025-09-18 | 2025-09-18 | 0d | 2025-03-28 | 2025-03-28 | 32164d |  | CPT | PMO |  | Control Points | 5.0 | PMO | Control Points | 272.33 | Green | GREEN | T1-CP-3000 | PSG | T1 |
| 3049 | 1.13.5.4 | Control Point 5 - Cut Over to New Settlement Timetable (incl. Control Point Report approval) | milestone | 0d | 2027-06-23 | 2027-06-23 | 3044SS |  |  | 2027-06-23 | 2027-06-23 | 0d | 2026-12-07 | 2026-12-07 | 31705d |  | CPT | CPT | D33 - Control Point 6 Approval | Control Points | 5.0 | PMO | Control Points | 915.33 | Green | GREEN | T1-CP-4000 | PSG | T1 |
| 3050 | 1.14 | **MILESTONE RANGE CHECKPOINTS** |  | 1160d? | 2022-10-31 | 2027-04-12 |  |  |  | 2022-10-31 | 2027-04-12 | 436d | 2025-01-13 | 2026-09-15 | 31757d |  | N/A | N/A |  | Milestone Range Checkpoints |  | N/A | Milestone Range Checkpoints |  |  |  |  |  |  |
| 3051 | 1.14.1 | **M10, M11, M12 and M13 milestone checkpoint** |  | 0d | 2025-07-31 | 2025-07-31 |  |  |  | 2025-07-31 | 2025-07-31 | 0d | 2025-01-13 | 2025-01-13 | 32199d |  | N/A | N/A |  | Milestone Range Checkpoints | 5.0 | N/A | Milestone Range Checkpoints |  |  |  |  |  |  |
| 3052 | 1.14.1.1 | M10, M11, M12, and M13 milestone checkpoint - date approval | milestone | 0d | 2025-07-31 | 2025-07-31 | 2709FS-3mo, 2711FS-3mo, 2707FS-3mo, 1774FS-3mo |  |  | 2025-07-31 | 2025-07-31 | 0d | 2025-01-13 | 2025-01-13 | 32199d |  | CPT | CPT |  | Milestone Range Checkpoints | 5.0 | PMO | Milestone Range Checkpoints | 223.33 | Green | GREEN | T2-MR-0100 | PSG | T2 |
| 3053 | 1.14.2 | **M14 milestone checkpoint** |  | 0d | 2026-08-06 | 2026-08-06 |  |  |  | 2026-08-06 | 2026-08-06 | 0d | 2025-12-23 | 2025-12-23 | 31934d |  | N/A | N/A |  | Milestone Range Checkpoints | 5.0 | N/A | Milestone Range Checkpoints |  |  |  |  |  |  |
| 3054 | 1.14.2.1 | M14 milestone checkpoint - date approval | milestone | 0d | 2026-08-06 | 2026-08-06 | 2305FS-3mo |  |  | 2026-08-06 | 2026-08-06 | 0d | 2025-12-23 | 2025-12-23 | 31934d |  | CPT | CPT |  | Milestone Range Checkpoints | 5.0 | PMO | Milestone Range Checkpoints | 594.33 | Green | GREEN | T2-MR-0200 | PSG | T2 |
| 3055 | 1.14.3 | **M15 milestone checkpoint** |  | 0d | 2027-02-15 | 2027-02-15 |  |  |  | 2027-02-15 | 2027-02-15 | 0d | 2026-07-14 | 2026-07-14 | 31797d |  | N/A | N/A |  | Milestone Range Checkpoints | 5.0 | N/A | Milestone Range Checkpoints |  |  |  |  |  |  |
| 3056 | 1.14.3.1 | M15 milestone checkpoint - date approval | milestone | 0d | 2027-02-15 | 2027-02-15 | 2713FS-3mo |  |  | 2027-02-15 | 2027-02-15 | 0d | 2026-07-14 | 2026-07-14 | 31797d |  | CPT | CPT |  | Milestone Range Checkpoints | 5.0 | PMO | Milestone Range Checkpoints | 787.33 | Green | GREEN | T2-MR-0300 | PSG | T2 |
| 3057 | 1.14.4 | **M16 milestone checkpoint** |  | 1160d? | 2022-10-31 | 2027-04-12 |  |  |  | 2022-10-31 | 2027-04-12 | 0d | 2026-09-15 | 2026-09-15 | 31757d |  | N/A | N/A |  | Milestone Range Checkpoints | 5.0 | N/A | Milestone Range Checkpoints |  |  |  |  |  |  |
| 3058 | 1.14.4.1 | M16 milestone checkpoint - date approval | milestone | 0d | 2027-04-12 | 2027-04-12 | 2948FS-3mo |  |  | 2027-04-12 | 2027-04-12 | 0d | 2026-09-15 | 2026-09-15 | 31757d |  | CPT | CPT |  | Milestone Range Checkpoints | 5.0 | PMO | Milestone Range Checkpoints | 843.33 | Green | GREEN | T2-MR-0400 | PSG | T2 |
